# Work_plan_3gpp_190315_Rel15_onwrds

Schedule from MS Project, 2000-01-01 to 2119-12-15, A marks actual dates.

## Calendars

- Standard: Mon-Fri 08:00-12:00, 13:00-17:00; Sat-Sun off. Exceptions (off unless hours are given): 2000-01-15 08:00-12:00, 13:00-17:00, 2009-05-30 08:00-12:00, 13:00-17:00, 2011-08-27 to 2011-08-28 08:00-12:00, 13:00-17:00, 2011-09-24 08:00-12:00, 13:00-17:00, 2012-06-02 08:00-12:00, 13:00-17:00, 2012-09-01 08:00-12:00, 13:00-17:00, 2012-11-18 08:00-12:00, 13:00-17:00, 2012-11-24 08:00-12:00, 13:00-17:00, 2013-02-16 08:00-12:00, 13:00-17:00, 2013-06-02 08:00-12:00, 13:00-17:00, 2013-08-10 to 2013-08-11 08:00-12:00, 13:00-17:00, 2013-09-14 08:00-12:00, 13:00-17:00, 2014-03-01 08:00-12:00, 13:00-17:00, 2014-08-24 08:00-12:00, 13:00-17:00, 2014-09-21 08:00-12:00, 13:00-17:00, 2014-10-05 08:00-12:00, 13:00-17:00, 2016-06-18 08:00-12:00, 13:00-17:00.

## Resources

| Resource |
| --- |
| NP |
| N1 |
| N2 |
| N3 |
| N4 |
| N5 |
| TP |
| T1 |
| T2 |
| T3 |
| RP |
| R1 |
| R2 |
| R3 |
| R4 |
| SP |
| S1 |
| S2 |
| S3 |
| S4 |
| S5 |
| PCG |
| GP |
| No |
| CN4 |
| ? |
| WG G2 |
| G2 |
| G1 |
| G4 |
| G3 |
| All |
| Generic |
| MLST |
| G5 |
| S3, G2 |
| WG T2 |
| GP,G1 |
| G4,G5 |
| OMA |
| GP-G2 |
| Yes |
| GP, |
| N4, |
| GP, N1 |
| CT5 |
| C5 |
| C1 |
| C4 |
| C3 |
| C6 |
| G1, |
| 4 |
| ct |
| c,s,r |
| CT,RAN,SA |
| G2, |
| G1, G3 |
| CT6 |
| CT1 |
| CT1, CT3, CT4 |
| C1, C3, C4 |
| CP |
| R5 |
| C |
| Rel-8 |
| GP, G2 |
| R1,R4 |
| S5,C1 |
| CT,RAN,SA,GERAN |
| S3,C1,C4 |
| 5 |
| S1,C1,C3,C4,S5 |
| S1,C1,C3,C5 |
| S1,C1,C3,C4 |
| S1,S5 |
| S2,S3 |
| RAN,SA |
| RP,S5 |
| S2,CT |
| S1,CT |
| S1,CT,GERAN |
| S1,C5 |
| S3,CT |
| S4,CT |
| C1,SA |
| S1,S2 |
| S1,S4 |
| S2,S2,S3,CT |
| S2,S3,CT |
| S1,CT,GX |
| S1,S4,CT |
| S2,S2,S3,S5,CT |
| S1,S2,CT |
| S1,S2,S3,CT |
| S1,S2,S3,S5CT |
| S1,S2,S3,S5,CT |
| S2,S5,CT |
| S4,S3 |
| S1,C1 |
| CP,C1 |
| C1,C3 |
| C1,C3,C4 |
| S1,S5,CT |
| C4,C3 |
| CP,RAN,SA,GERAN |
| S1,S2,S3,S5,CP |
| S2,S3,CP |
| S2,CP |
| S1,CP,GX |
| S1,CP |
| S1,S4,CP |
| S1,S2,CP |
| S1,S2,S3,CP |
| S2,S5,CP |
| S3,CP |
| S1,S5,CP |
| RAN,SA,GERAN |
| S1,S2,S3,S5,C1,C3,C4,C6 |
| S2,S3,C1,C3,C4 |
| S2,C4 |
| S2,C1,C3,C4 |
| S2,C1,C4 |
| S2,S3,C1,C4 |
| S1,C1,C4,G2 |
| C1,C4 |
| S1,C1,C3 |
| S1,S4,C1,C3,C4 |
| S1,S2,S3,C1,C3,C4 |
| S2,S5,C3 |
| S1,S2,C1,C4 |
| S2,C1 |
| S2,C1,C3 |
| S3,C1,C3,C4 |
| S1,S5,C1,C3,C4 |
| S2,C3,C4 |
| C3,C1 |
| R2,R4 |
| R2,R5 |
| RP,R5 |
| RP,S5,R5 |
| R1,R5 |
| S1,C1,R5 |
| S1,C1,S4,R5 |
| GERAN |
| G3new |
| G1, G3new |
| C4,C1,C3 |
| R1.R4 |
| R1, R4 |
| R2,R3 |
| C3,C4 |
| S4,C3 |
| S4,C3,C1,C4 |
| S1,S2,C1 |
| S1,S2<C1,C3,C4 |
| S1,S2,C1,C3,C4 |
| S5,C1,C3,C4 |
| GP,C4 |
| C4,C1 |
| S2,S1 |
| RP,SP,GP |
| RP,SP,CP,GP |
| CP,GP,RP,SP |
| GP,C4,S4 |
| S1,C1,C4 |
| S1,S2,C3,C1 |
| R2,R4,R3 |
| CP,GP, RP,SP |
| S2,S1,C1,S5 |
| S2,S1,C1 |
| S1,C1,S4 |
| S1,S2,GP,C4,R2 |
| S1,GP,R2 |
| S1,C6 |
| S1,S2,C1,S4 |
| S2,S3,S5,C1,C3,C4 |
| S2,S5,C1 |
| S2,S3,S5 |
| CP,GP, RP,SP,TP |
| S2,C4,C1 |
| S1,C1,C4,S3 |
| S2,S5 |
| S3,C1 |
| S3,C4 |
| S1,C4 |
| S2,S5,C3,C1 |
| S2,S1,S5,C1,C4 |
| S1,R1,C3 |
| S1,C1,R2 |
| S2,S1,C1,C4 |
| S1,C1,C6 |
| GP,S4,C4,C1,C3 |
| C3,C1,C4 |
| S1,C4,C1 |
| S1,S3 |
| S1,S2,S5,C3,C4 |
| R4,G1 |
| G1,R4 |
| RP,GP |
| R4,GP |
| R3,R2 |
| C6,RP,SP |
| R5,C6 |
| CP,RP,SP |
| RP,SP,CP |
| R3,S5 |
| S1,S2,RP |
| S1,S2,S5,RP |
| S2,S1,RP |
| Rel-9 |
| S3,C6 |
| S1,S2,S3,S5,RP |
| S2,S1,S3 |
| S1,S2,S3 |
| S1,S2,S3,S5 |
| C6,R5 |
| S1,S2,RP,GP |
| S1,S2,S4,S5,RP,GP |
| GP,G2 |
| GP,GP, N1 |
| GP,S2,G1,G2 |
| GP,R2,R3,S2,G1,G2 |
| GP,S2,S5,R2,R3,G2,G1 |
| GP,R3 |
| N4,S2 |
| GP,RP |
| GP,S2,RP |
| G5,G4 |
| G4,R3 |
| S2,R2,R4 |
| S1,S2,R2,R4 |
| GP,S5 |
| S1,S2,S5 |
| R4,R5 |
| R4,R2,R3,R5 |
| S2,S5,N4,RP |
| S1,S2,S3,S5,NP |
| S2,S4,S5 |
| T2,S1,S4,S5 |
| SP,RP |
| S2,RP |
| S1,S2,CP,G2 |
| CP,SP |
| S1,G2 |
| SP,CP |
| S1,S2,S5,C3 |
| S1,C1,S3 |
| G1,G3new |
| C4, C3, C1C4 |
| C4,C3,C1 |
| S1,S2,S3,S5,R2,R3,R4 |
| S1,S2,S3,R2 |
| S2,S3,S5,C4,R2 |
| S1,S5,C1 |
| S1,S2,S3,C1,C3,C4,R2 |
| Ggp |
| S3,S2,C1,C4,G2 G3new |
| R1,R2,R3,R4 |
| R4,R1,R2,R3 |
| R4,R2,R3 |
| S1,C1,C4,R2 |
| R4,R2 |
| S2,C4,R2,R4 |
| S2,C4,R2 |
| S2,S3,S5,C3,C4,R2 |
| S1,S2,S4,T2 |
| S1,S2,S4 |
| S1,S2,S4,R5 |
| S3,S2,C1,C4,G2,G3new |
| GP,C1 |
| S1,S5,C4 |
| S1,S2,S3,S5,R2,R3,R4,GP |
| GP,C4,C3,C1 |
| SMG9 |
| SMG1 |
| SMG2 |
| N3,R5 |
| N1, N2, N4, G1, G2, R3, S1, SMG2 |
| S1,SMG1 |
| SMG1,N4 |
| N1,C1,N4,S1,T2,G2,SMG1,SMG2,SMG3,SMG7,SMG9 |
| SMG1,N2 |
| S1,S2,N2,N4 |
| N4,N2 |
| G1,G2 |
| G1,G2,C1 |
| G1,G2,N1 |
| SMG2, SMG1, SMG3, SMG4, SMG7, SMG9, SMG10, G1, G2, G3, N1, N3, T2 |
| SMG2,G1 |
| S1,G1,G2 |
| SMG1,N1,G1,G2 |
| G2,G1 |
| G1,G2,G3,S1,S2,SMG1,SMG2,SMG7,N1,N2,N3,N4,T2 |
| 23.003, 23.008, 29.060 |
| S1, S2, SMG1, SMG2, SMG12, G2, N1, N2, N4 |
| S1,S2,SMG1,SMG2,SMG12,G2,N1,N2,N4 |
| S1,SMG2,N1,N2,N4 |
| SMG1,T2 |
| S1,N1,N2,N4 |
| S1,S2,N5 |
| SMG2,SMG7,G2,T2 |
| S3,N1,N2,N3 |
| S3,N1,N2,N4 |
| SMG9,T3 |
| SMG2,SMG3,SMG7,G2,N2 |
| SMG2,N1,G1,G2 |
| S1,N2 |
| N1,N3 |
| S2,N1 |
| N1,N2,N4 |
| N2,N1,N4 |
| N2,N4 |
| S1,T3 |
| T2,N3 |
| S3,N2 |
| T2,S1 |
| S1,N4 |
| SMG1,SMG2,SMG7 |
| N1,S1,T1 |
| SMG1,SMG3 |
| N4,S2,N1 |
| S1,S2,SMG1,SMG2,SMG7,G1,G2,G3,N1,N2,N3,N4,T2 |
| SMG1,N3 |
| S1,N3 |
| CP,SP,SMG |
| CP,SP,TP,GP,SMG |
| NP,SP,TP,GP,SMG |
| NP,GP, RP,SP,TP |
| SMG2,SMG1,SMG3,SMG4,SMG7,SMG9,SMG10,G1,G2,G3,N1,N3,T2 |
| S1,N2,N4 |
| S1,S2,S3,C1,C3,C4,R2,R3 |
| R2,R3,R1,R4 |
| R2,R3,R4 |
| R2,R1,R3,R4 |
| S2,C4,R2,R3,R4 |
| S2,C4,R2,R1,R3,R4 |
| S2,S3,S5,C3,C4,R2,R3,R4 |
| R1,R2,R4 |
| R3,R1,R4 |
| S2, |
| S2,G2, |
| S1,S2,G2, |
| S1,S2,G2,R2,R3, |
| S1,S2,C4,G2,R2,R3 |
| S1,S2,N4,G2,R2,R3 |
| S1,S2,SMG1,SMG2,SMG12,G2,N1,N2,N4,R2,R3 |
| S1,SMG1,T2 |
| S1,SMG1,S2 |
| S1,N4,N2 |
| T2,N1,N3 |
| S3,N2,N4 |
| SMG1,SMG2,SMG3,SMG7,SMG9,N1,C1,N4,S1,T2,G2 |
| SMG1,N2,N4 |
| S2,T2,N1,N2,N4 |
| S1,T2 |
| S1,S2,C4 |
| S1,S2,N4,RP |
| S2,N4 |
| S1,S2,N3,N4,RP |
| S1,S2,SMG1,SMG2,SMG12,T2,G2,N1,N2,N4,R2,R3 |
| S1,T2,N1,N3 |
| S1,S2,SMG1,SMG2,SMG12,T2,G2,N1,N2,N3,N4,R2,R3 |
| S1,S2,S3,SMG1,SMG2,SMG12,G2,N1,N2,N4,R2,R3 |
| S1,S2,SMG,G1,G2,G3,N1,N2,N3,N4,T2 |
| S1,S2,SMG,T2,G2,N1,N2,N3,N4,R2,R3 |
| S1,S3,SMG,G1,G2,G3,N1,N2,N3,N4,T2 |
| S1,S3,T2,N2,N4 |
| S1,S2,SMG,T2,G1,G2,G3,N1,N2,N3,N4 |
| G2,S2 |
| T1,R5 |
| R5,T1 |
| S1,S2,S4,T1,R5 |
| S1,S2,S4,S5,T1,RP,GP |
| S1,S2,S3,S5,R2,R3,R4,GP,C1 |
| S1,S2,S3,SMG1,SMG2,SMG12,N1,N2,N4,R2,R3 |
| S1,S2,SMG,T2,N1,N2,N3,N4,R2,R3 |
| NP,SP,TP,SMG |
| S1,S2,SMG,T2,N1,N2,N3,N4 |
| SMG,N1 |
| SMG |
| S1,S2,SMG1,SMG2,SMG7,N1,N2,N3,N4,T2 |
| SMG2,SMG1,SMG3,SMG4,SMG7,SMG9,SMG10,N1,N3,T2 |
| S1,SMG |
| SMG2,SMG7,T2 |
| SMG2,S2 |
| N1,N2,N4,R3,S1,SMG |
| SMG2,SMG3,SMG7,N2 |
| SMG1,SMG2,SMG3,SMG7,SMG9,N1,C1,N4,S1,T2 |
| S1,S2,SMG,N3,N4,RP |
| S1,S2,S4,SMG,N3,N4,RP |
| S2,C1,C4,R2,R1,R3,R4 |
| R2,S2,S4 |
| G3new,R5 |
| GP,R4 |
| S2,S4,R2 |
| SP,GP |
| RP,SP |
| S2,S1,S3,S5 |
| S3,S1 |
| N4,N1,N2,S2 |
| S2,G1,G2,R2,R3 |
| S2,G1,G2 |
| G1,G2,R2,R3 |
| N4,T3 |
| S3,S2,N1,N4,T3,OMA |
| T2,S1,S4,S5,OMA |
| S2,N3 |
| S4,S1 |
| N4,N3,S1 |
| R5,G3new |
| R4,R2,R1 |
| S2,R2 |
| C3, C4,C1 |
| S3,C1,C4,C3 |
| C1,C4,C3 |
| S2,C1,C4,C3 |
| R3,R5 |
| S1,S2,C3 |
| R1,R2 |
| S3,C1,C4,G2,G3new |
| R1,R3 |
| GP,N1 |
| R1,R2,R3 |
| R3,R2,R4 |
| R4,R3 |
| S1,S2,R2,R3 |
| S1,S2,S3,C1,C3,C4,R2,R3,R5 |
| S2,S1,S5 |
| C4, C1 |
| C3, C1, C4 |
| S2,S1,S3,S5,C4,C1 |
| S2,C3,C1,C4 |
| S2,S1,S5,C3 |
| GP,S2,C1 |
| GP,S2,C1,G2 |
| G2,S2,C1 |
| v |
| G3new,G1,G2 |
| G1,G2,C1,G3new |
| S2,S1,S5,C1,C3 |
| C1,C3,C4,R5 |
| R2,R1 |
| S1<S2,N1,R2,R5 |
| S1,S2,N1,R2,R5 |
| S2,R5 |
| S1,S2,S5,R5 |
| S2,C1,C4,R2,R1,R3,R4,R5 |
| S1,S2,S3,S5,NP,R5 |
| S1,S2,S4,S5,RP,R5,GP |
| S1,S2,S3,S5,C1,C6,R2,R3,R4 |
| S1,S2,S3,S5,C1,C6,R2,R3,R4,GP |
| S4,R2 |
| S1,S2,C1,C4,G2 |
| S4,C3,C4 |
| S5,C1,C4 |
| S2,C4,C3,C1 |
| C4, C3, C1 |
| S2,S4,R2,C4,C3,C1 |
| GP1,GP2 |
| GP,GP1,GP2 |
| GP,G1,G2 |
| G2,R3 |
| S1,S2,S3,C1,C3,C4,G2 |
| GP,G1,C1 |
| S1,S2,C4,C3,C1 |
| - |
| GP,G1,G2,G3new |
| S1,S2,S3,C1,C3,C4,G2,R2,R3 |
| S1,S2,C1,C3,C4,G2,R2,R3 |
| C1,C6 |
| GP,G2,C4 |
| S2,C3 |
| R5,R4 |
| C4,GP,G2 |
| S1,S2,C1,C4,G2,R2,R3 |
| R1,R2,R4,S3 |
| S2,S5,C3,C1,C4 |
| S2,S4,C4,C3,C1 |
| S2,S4 |
| S3,S1,S2 |
| S1,S2,S3,C1,R2 |
| S3,S1,S2,C1,R2 |
| S2,C3,S5 |
| S1,S2,C1,C4,C3,G2,R2,R3 |
| S5,C4 |
| S2,S1,C3 |
| C1,C4,C3,C6 |
| S1,S2,C1,C4,C3,C6,G2,R2,R3 |
| R1,R2,R4,S3,C4,C6 |
| R4,R1,R4,R1,R2,R3,R3 |
| S2,R3,R2 |
| S1,S2,S5,CP |
| S1,S3,CP |
| C6,C1 |
| R4,R2,R1,R3 |
| R3,R1,R2 |
| R1,R4,R2,R3 |
| S2,C4,C1,C3 |
| R3,R1,R2,R4 |
| C4,S1 |
| S2,S5,R3,GP, |
| S2,S5,R3,GP |
| S1,S2,S3,S5,C1,C3,C4 |
| S2,S3,S5,C1,C3,C4,C6 |
| S5,S1 |
| 03.06.2011 |
| CT1 CT3, CT4 |
| CT3, |
| CT4 |
| CT3 |
| GP,G2,G1 |
| S5,S1,C1 |
| SP,RP,CP |
| SP,CP,GP,RP |
| R1,R2,R4,R3 |
| R4,R2,R5 |
| R2,R4,R5 |
| R1,R2,R4,S2,S3,C4,C6 |
| C1-IETF |
| S4-IETF |
| C1-IETF, C3-IETF, C4-IETF |
| S3-IETF |
| C4-IETF |
| C1-IETF, C3-IETF |
| S2,S4,C1,R2 |
| S2,S4,C3,C4 |
| S2,S4,C1,C3,R2 |
| S1,S2,C1,IETF |
| S4,IETF |
| C1,C4,IETF |
| S2,S4,C1,C3,R2,IETF |
| S3,C1,C4,C3,IETF |
| S3,C4,IETF |
| C1,IETF |
| S1,S2,S3,S5,C1,C3,C4,C6,IETF |
| S2,S3,C1,C4,IETF |
| S1,S2,C1,C3,C4,IETF |
| C1,C3,C4,IETF |
| S1,S5,C1,C3,C4,IETF |
| C1,C3,IETF |
| S2,C1,C3,C4,IETF |
| S2,S4,C3,C4,IETF |
| S5,C1,C4,IETF |
| S5,C1,C3,C4,IETF |
| S2,S3,S5,C1,C3,C4,IETF |
| S2,IETF |
| S3,C1,C3,C4,IETF |
| S2,S3,C1,C3,C4,IETF |
| S3,S2 |
| S3,S2,C1 |
| S3,S1,S2,C1 |
| S2,S5,N3 |
| S1,S2,S3,S5,N1,N3,N4,T3 |
| S5,N4,R3 |
| S1,S2,S5,C1,C4,C3,C6,G2,R2,R3 |
| S2,N1,N4,R3,GP |
| T2,S3 |
| S3,N4,N1 |
| S2,N3,N4 |
| S3,T2 |
| S2,S1,S3,S5,RP,GP |
| S1,S2,S3,S5,R5 |
| S1,S2,S3,S5,NP,T3,T1,R5 |
| S3,T3 |
| GP,S3 |
| S1,S2,S3,S4,S5,RP,R5,GP |
| N1,N4 |
| S1,S2,S3,S4,N1,N3,N4,OMA |
| S2,C1,C3,C4,G2,R2,R3 |
| S1,C4,C3 |
| S2,S1,C1,C4,IETF |
| C1,C3,C4,C6 |
| C4,C1,C6 |
| S1,S2,S3,C1,C3,C4,C6 |
| S2,S1,C1,C3,C4 |
| S1,S2,C1,C3 |
| C1.IETF |
| C1-IETF,C4-IETF |
| G1,C1 |
| G1,S2,C4 |
| G2,S2,C4 |
| R1,R2,R3,R4,R5 |
| R2,R4,R3,R5 |
| R3,R2,R5 |
| R2,R3,C1,C6 |
| S1,S2,S3,C1,C3,C4,C6,R2,R3 |
| R4,R1 |
| S2,S4,C4,C3,C1,IETF |
| S2,C4,C3 |
| S3.C4,C1 |
| G2,C4 |
| R4,G1,G3new |
| C4,G2 |
| S3,C4,C1 |
| R2,R3,R5 |
| R1,R2,R4,R5 |
| S1,S2,S3,S5,C1,C6,R2,R3,R4,R5,GP |
| S1,C1,C4,R2,R5 |
| S2,S3,S5,C3,C4,R2,R3,R4,R5 |
| R2,R1,R3,R4,R5 |
| S3-IETF, C1-IETF |
| S3-IETF,C1-IETF |
| C1-IETF,C3-IETF |
| S2-IETF |
| S2,S1,C1,C3,C4,IETF |
| 25.101, 25.104, 25.141, 25.317 |
| S1,G2,S2,C1 |
| S1,C1,C4,R2,R3,R5 |
| S5,S2 |
| S4,C3,C4,IETF |
| S4,S3,C3,C4,IETF |
| S4,S3,C3,C4 |
| S4,S3,IETF |
| S1,S2,S3,S5,C1,C3,C4,C6,R2,R3 |
| C1,C4,C6 |
| S1,S2,S5,C1,C4,C6,G2,R2,R3 |
| GP,G1,C1,G3new |
| S2,S5,C1,C3 |
| C4,C3,G2 |
| S2,S1,S5,C3,C1,C4 |
| C3,C4,C1 |
| S2,S1,S5,C3,C4,C1 |
| RAN1 |
| RAN2 |
| RAN3 |
| RAN4 |
| R4,R2,R3, |
| Feasibility Study on LTE Device to Device Communications – Radio Aspects |
| SMG1,SMG2,SMG3,SMG7,SMG9,N1,N4,S1,T2 |
| C3-IETF, C4-IETF |
| S3-IETF,C1-IETF,C3-IETF |
| C3-IETF |
| C3,IETF |
| S2,C1,C4,C3,IETF |
| S1,S2,S3,C1,C3,C4,R2,R3,R5,IETF |
| C1-IETF,C3-IETF,C4-IETF |
| C4,C1,C3,IETF |
| S2,C4,C1,C3,IETF |
| C1,C4,C3,IETF |
| S2,S1,T2,N1,N4,R3,R2 |
| S2,S1,S2,S1,N1,N4 |
| S2,S1,N1,N4 |
| S2,R2,G1 |
| S2,S1,S3,S5,N4,R2,R3,GP |
| S1,S2,N4 |
| S2,OMA |
| S2,N4,OMA |
| S2,S5,N4,R2,R4 |
| S2,S5,N4,R2,R4,OMA |
| GP,R2 |
| S1,S2,GP,R2 |
| G1,G3 |
| S1,G2,R2 |
| S2,S5,N4,R2,R4,R5,OMA |
| SR5 |
| S3,C4,C1,R5 |
| S3,S1,C1 |
| S2,C4,C3,G2 |
| SP,CP,RP |
| S3,R5 |
| GP,G2,G3new |
| S1,S2,S3,S4,S5,N1,N3,RP,R5,GP |
| S1,S2,S3,S4,S5,N1,N3,RP,R5,T1,GP |
| S1,S2,S3,S4,S5,N1,N3,RP,R5,T1,GP,G2,G3new |
| S1,S2,S3,S4,S5,N1,N3,R2,R4,R5,T1,GP,G2,G3new |
| S1,S2,S5,C1,C4,C6,G2,R2,R3,G3new |
| SP,CP,RP,GP |
| G2,G1,G3new |
| G2,G1,C1,G3new |
| RAN |
| R |
| S2,S1,S3,S5,R2 |
| S2,S1,S3,S5,R2,R3 |
| S1,S2,S5,C1,C4,C6,G2,R2,R3,R5,G3new |
| C1,C4,R5,IETF |
| C1,R5 |
| R3,R1 |
| R3,GP |
| S3,IETF |
| S1,S2,S5,C1,C3,C4,C6,R2,R3 |
| S3,C4,C1,C3 |
| C1,C4,S1 |
| C1,C4,R3 |
| R2,R1,R3 |
| R1,R4,R2,R3,R5 |
| RAN5 |
| S2,C4,C1,R3 |
| G1,G2,G3new |
| S4,C1 |
| S4,C4,C1,C3 |
| 14/06/2013 08:00 |
| S2,C1,C3,IETF |
| C3, C1 |
| R3,C4 |
| S2,S1,C1,C3 |
| R3,S2,C4 |
| R% |
| G1,C1,G3new |
| R3,S2,C4,G2 |
| S1,S3,N4 |
| S1,OMA |
| S1,S2,S4,OMA |
| S5,S2,N3 |
| S3,C4,C1,C3,IETF |
| S1,S2,S5,C1,C3,C4,C6,R2,R3,R5 |
| S2,S1,S5<c3 |
| S2,C1,C4,C6 |
| S2,S1,S3,C1,C4,C6 |
| S2,S1,S3,C1 |
| R2,R3,R4,G2,G1,G3new |
| C1,C3,R5 |
| ,C4,C6 |
| S2,S1,S3,C1,C4,C6,R2 |
| S2,S1,S3,C1,C4,C6,R2,R3 |
| S2,S1,S3,C1,C3,C4,C6,R2,R3 |
| S1,S2,S3,IETF |
| S1,S2,S3,C1,C3 |
| S1,S2,S3,C4,C1,C3 |
| C1,S1 |
| C34 |
| S1,S2,S3,C1,C4,IETF |
| IETF |
| SMG12 |
| SMG7 |
| SMG3 |
| SMG4 |
| SMG10 |
| C3-IETF,C4-IETF |
| NP,GP,RP,SP,TP |
| S3,G2 |
| R2,S2 |
| R2,S2,C1 |
| R2,C1 |
| S1` |
| R2,S1,C1 |
| C1-IET |
| 18/06/2014 08:00 |
| C4-IET |
| RAN1 (primary) |
| C3.S2 |
| C3-IET |
| S6 |
| ` |
| SA5 |
| Rel-13 |
| Rel-14 |
| 18/06/2015 |
| SA2 |
| S3-IET |
| SA1 |
| SA4-IETF |
| R6 |
| S3LI |
| ITU-R AH |
| Rel-15 |
| CT1-IETF |
| FRASE |
| SP-180438 |
| SP-180439 |
| SP-180440 |
| SP-180441 |
| SP-180442 |
| SP-180443 |
| SP-180387 |
| SP-180388 |
| SP-180390 |
| SP-180391 |
| S5-IETF |

## Schedule

| ID | WBS | Task | Type | Duration | Start | Finish | Complete | Remaining | Total slack | Free slack | Constraint | Resources | Work | Actual work | Release | Acronym | PCG approved | Impacted TSs and TRs | WI rapporteur name | WI rapporteur e-mail | TSG approved |
| --- | --- | --- | --- | --- | --- | --- | --- | --- | --- | --- | --- | --- | --- | --- | --- | --- | --- | --- | --- | --- | --- |
| 1 | 1 | Work Plan 3GPP version March 15th 2019 |  | 1d? | 2019-03-07 | 2019-03-07 |  |  | 26291d |  |  |  |  |  | Rel-16 |  |  |  |  |  |  |
| 2 | 2 | Includes the WIDs proposed at TSG#83 |  | 1d? | 2019-03-07 | 2019-03-07 |  |  | 26291d |  |  |  |  |  | Rel-16 |  |  |  |  |  |  |
| 3 | 3 | Next: Rel-16 St.2: 06/19, St.3: 12/19. Rel-17: St.1 80% ready 09/19, 100% 12/19 |  | 1d? | 2019-03-07 | 2019-03-07 |  |  | 26291d |  |  |  |  |  | Rel-16 |  |  |  |  |  |  |
| 5 | 4 | Release 17 | milestone | 0d? | 2016-03-15 A | 2016-03-15 A | 100% |  |  |  | start no earlier than 2016-03-15 |  |  |  | Rel-17 |  |  |  |  |  |  |
| 6 | 5 | Release 17 on Use of 5G by different sectors ("verticals") | milestone, manual | 0d? | 2016-06-09 A | 2016-06-09 A | 100% |  |  |  | finish no earlier than 2016-06-09 |  |  |  | Rel-17 |  |  |  |  |  |  |
| 7 | 6 | Study on Asset Tracking Use Cases |  | 202d? | 2018-09-06 A | 2019-06-14 | 45% | 111.1d? | 26220d |  | finish no earlier than 2019-06-14 | S1 | 1616h | 242.4h | Rel-17 | FS_5G_ATRAC | 41 | 22.836 | Thierry Berisot, NOVAMINT | tberisot@novamint.com | 81 |
| 8 | 7 | Study on Communication Services for Critical Medical Applications |  | 267d? | 2018-09-06 A | 2019-09-13 | 65% | 93.45d? | 26155d |  | finish no earlier than 2019-09-13 | S1 | 2136h | 320.4h | Rel-17 | FS_CMED | 41 | 22.826 | Mathieu Lagrange, b<>com | mathieu.lagrange@b-com.com | 81 |
| 9 | 8 | Study on application layer support for Factories of the Future in 5G network |  | 266d? | 2019-03-07 A | 2020-03-12 | 5% | 252.7d? | -65d | 0d | finish no later than 2019-12-12 | S6 | 2128h |  | Rel-17 | FS_FFAPP |  | new | Shao Weixiang, ZTE Corporation | shao.weixiang@zte.com.cn | 82 |
| 10 | 9 | Study on supporting Unmanned Aerial Systems Connectivity, Identification, and Tracking |  | 331d | 2018-12-06 | 2020-03-12 |  |  | 26026d |  | start no earlier than 2018-12-06 | S2 | 2648h |  | Rel-17 | FS_ID_UAS_SA2 |  |  | Qualcomm Incorporated, Stefano Faccin | sfaccin@qti.qualcomm.com | 82 |
| 11 | 10 | Study on application layer support for Unmanned Aerial System (UAS) |  | 267d | 2018-12-06 | 2019-12-13 |  |  | 26090d |  | start no earlier than 2018-12-06 | S6 | 2136h |  | Rel-17 | FS_UASAPP |  | new | Niranth Amogh, Huawei | namogh@huawei.com | 82 |
| 12 | 11 | Study on enhancement for Unmanned Aerial Vehicles (UAVs) |  | 332d? | 2018-09-06 A | 2019-12-13 | 70% | 99.6d? | 26090d |  | finish no earlier than 2019-12-13 | S1 | 2656h | 531.2h | Rel-17 | FS_EAV | 41 | 22.829 | Qun Wei, China Unicom | weiqun5@chinaunicom.cn | 81 |
| 13 | 12 | Release 17 other Features | milestone, manual | 0d? | 2016-06-09 A | 2016-06-09 A | 100% |  |  |  | finish no earlier than 2016-06-09 |  |  |  | Rel-17 |  |  |  |  |  |  |
| 14 | 13 | Verification-modified Calling Name Display |  | 11d? | 2019-03-07 A | 2019-03-21 A | 100% |  |  |  | finish no earlier than 2019-03-21 | S1 | 88h | 88h | Rel-17 | VMOD_DISPLAY |  | 22.173 | Hala Mowafy, Ericsson | Hala.Mowafy@ericsson.com |  |
| 15 | 14 | Support of Immersive Teleconferencing and Telepresence for Remote Terminals |  | 526.88d | 2018-12-13 | 2020-12-18 |  |  | 25825d |  | start no earlier than 2018-12-13 | S4 | 4215h |  | Rel-17 | ITT4RT |  | 26.114; 26.223 | Ye-Kui Wang , Huawei Technologies Co. Ltd. | yekui.wang@huawei.com |  |
| 16 | 15 | Terminal Audio quality performance and Test methods for Immersive Audio Services |  | 456.88d | 2019-03-07 | 2020-12-04 |  |  | 25835d |  |  | S4 | 3655h |  | Rel-17 | ATIAS |  | 26.260, new | Stéphane Ragot, Orange | stephane.ragot@orange.com |  |
| 17 | 16 | Integration of ONAP and 3GPP 5G management framework |  | 260.88d | 2019-03-07 | 2020-03-05 |  |  | 26031d |  |  | S5 | 2087h |  | Rel-16 | ONAP3GPP |  | 28.540; 28.622; 28.623; 28.532 | SMITH David K., AT&T | DS9930@att.com |  |
| 18 | 17 | Release 17 other Studies | milestone | 0d? | 2016-03-15 A | 2016-03-15 A | 100% |  |  |  | start no earlier than 2016-03-15 |  |  |  | Rel-17 |  |  |  |  |  |  |
| 19 | 18 | Study on enhanced Relays for Energy eFficiency and Extensive Coverage |  | 202d? | 2018-09-06 A | 2019-06-14 | 40% | 121.2d? | 26220d |  | finish no earlier than 2019-06-14 | S1 | 1616h | 323.2h | Rel-17 | FS_REFEC | 41 | 22.866 | Jose Luis Almodovar Chico, KPN | jose.almodovarchico@tno.nl | 81 |
| 20 | 19 | Study on Network Controlled Interactive Service in 5GS |  | 202d? | 2018-06-06 A | 2019-03-14 | 85% | 30.3d? | 26286d |  | finish no earlier than 2019-03-14 | S1 | 1616h | 969.6h | Rel-17 | FS_NCIS | 41 | 22.842 | YANG Ning, Oppo | yangning@oppo.com | 80 |
| 21 | 20 | Study on Audio-Visual Service Production |  | 266d? | 2018-06-06 A | 2019-06-12 | 80% | 53.2d? | 26222d |  | finish no earlier than 2019-06-12 | S1 | 2128h | 808h | Rel-17 | FS_AVPROD | 41 | 22.827 | Roland Beutler, EBU | Roland.Beutler@swr.de | 80 |
| 22 | 21 | **Study on Support for Multi-USIM Devices** |  | 331d | 2018-12-06 A | 2020-03-12 | 1% | 326.31d |  |  |  |  | 3695.04h |  | Rel-17 | FS_MUSIM |  |  |  |  |  |
| 23 | 21.1 | Study on Support for Multi-USIM Devices |  | 130.88d? | 2019-03-07 A | 2019-09-06 | 5% | 124.34d? | 5d |  | finish no later than 2019-09-12 | S1 | 1047.04h |  | Rel-17 | FS_MUSIM |  | New | Liao, Ellen C, Intel | ellen.c.liao@intel.com |  |
| 24 | 21.2 | Study on system enablers for multi-SIM devices |  | 331d | 2018-12-06 | 2020-03-12 |  |  | 0d |  |  | S2 | 2648h |  | Rel-17 | FS_MUSIM |  |  | Sašo Stojanovski, Intel | saso stojanovski intel com) | 82 |
| 25 | 22 | Study on Multimedia Priority Service (MPS) Phase 2 |  | 455d? | 2017-12-15 A | 2019-09-12 | 80% | 91d? | 26156d |  | finish no earlier than 2019-09-12 | S1 | 3640h | 1690h | Rel-17 | FS_MPS2 | 40 | 22.854 | Singh, Ray P; Vencore Labs | rsingh@vencorelabs.com | 78 |
| 26 | 23 | Study on Support for Minimization of service Interruption |  | 130.88d | 2019-03-07 | 2019-09-05 |  |  | 26161d |  |  | S1 | 1047h |  | Rel-17 | FS_MINT |  | New | SungDuck Chun; LG Electronics | sungduck.chun@lge.com |  |
| 27 | 24 | Study on enhancements for cyber-physical control applications in vertical domains |  | 130.88d | 2019-03-07 A | 2019-09-05 | 5% | 124.33d | 26161d |  |  | S1 | 1047h |  | Rel-17 | FS_eCAV |  | New | Michael Bahr, Siemens AG | bahr et siemens dod com |  |
| 28 | 25 | Study on Architectural enhancements for 5G multicast-broadcast services |  | 331.88d | 2019-03-07 | 2020-06-12 |  |  | 25960d |  |  | S2 | 2655h |  | Rel-17 | FS_5MBS |  | New | Dario Serafino Tonesi, Huawei | dario.tonesi@huawei.com |  |
| 29 | 26 | Study on service-based support for SMS in 5GC |  | 195.88d | 2019-03-07 | 2019-12-05 |  |  | 26096d |  |  | S2 | 1567h |  | Rel-17 | FS_SB_SMS |  | New | George Foti | George dot Foti at ericsson dot com |  |
| 30 | 27 | Study on enhancement of support for Edge Computing in 5GC |  | 260.88d | 2019-03-07 | 2020-03-05 |  |  | 26031d |  |  | S2 | 2087h |  | Rel-17 | FS_enh_EC |  | New | Hui Ni, Huawei | Hui.ni@huawei.com |  |
| 31 | 28 | Study on Application Architecture for enabling Edge Applications |  | 195.88d | 2019-03-07 | 2019-12-05 |  |  | 26096d |  |  | S6 | 1567h |  | Rel-17 | FS_EDGEAPP |  | New | Nishant Gupta, Samsung | nishant.gup@samsung.com |  |
| 32 | 29 | Study on System enhancement for Proximity based Services in 5GS |  | 331.88d | 2019-03-07 | 2020-06-12 |  |  | 25960d |  |  | S2 | 2655h |  | Rel-17 | FS_5G_ProSe |  | New | Qiang Deng, CATT | dengqiang1@catt.cn |  |
| 33 | 30 | Study on UPF enhancement for control and SBA |  | 261.88d | 2019-03-07 | 2020-03-06 |  |  | 26030d |  |  | S2 | 2095h |  | Rel-17 | FS_UPCAS |  | New | Dan Wang, China Mobile | wangdanyjy@chinamobile.com |  |
| 34 | 31 | Release 16 Features and related studies | milestone | 0d? | 2016-03-15 A | 2016-03-15 A | 100% |  |  |  | start no earlier than 2016-03-15 |  |  |  | Rel-16 |  |  |  |  |  |  |
| 35 | 32 | Enhancement of Ultra-Reliable (UR) Low Latency Communications (URLLC) | milestone | 0d? | 2017-12-15 A | 2017-12-15 | 31% | 0d? | 26611d |  |  |  |  |  | Rel-16 |  |  |  |  |  |  |
| 36 | 33 | Study on enhancement of URLLC supporting in 5GC |  | 197d? | 2018-03-15 A | 2018-12-14 | 90% | 19.7d? | 26350d |  | finish no earlier than 2018-12-14 | S2 | 1576h | 945.6h | Rel-16 | FS_5G_URLLC | 40 | 23.xyz; 23.725 | Hui Ni, Huawei | Hui.ni@huawei.com | 79 |
| 37 | 34 | Enhancement of URLLC support in the 5G Core network |  | 136d | 2018-12-13 A | 2019-06-20 | 50% | 68d | 26216d |  | start no earlier than 2018-12-13 | S2 | 1088h |  | Rel-16 | 5G_URLLC |  | 23.501; 23.502; 23.503 | Hui Ni, Huawei | Hui.ni@huawei.com | 82 |
| 38 | 35 | Study on the security of URLLC for 5GS |  | 137d? | 2018-09-06 A | 2019-03-15 | 20% | 109.6d? | 26285d |  | finish no earlier than 2019-03-15 | S3 | 1096h |  | Rel-16 | FS_5G_URLLC_SEC | 41 | New | Rong Wu, Huawei Technologies | Raina.wu@huawei.com | 81 |
| 39 | 36 | Study on EPC support for Mobility with Low Latency Communication |  | 196d? | 2017-12-15 A | 2018-09-14 | 75% | 49d? | 26415d |  | finish no earlier than 2018-09-14 | S2 | 1568h | 1176h | Rel-16 | FS_LLC_Mob | 40 | new 23.739 | Chris PUDNEY | chris dot pudney at vodafone dot com | 78 |
| 40 | 37 | Study on enht of systems using EPS for UR and Availability using commodity equipment |  | 197d? | 2018-03-15 A | 2018-12-14 | 10% | 177.3d? | 26350d |  | start no earlier than 2018-03-15 | S2 | 1576h | 157.6h | Rel-16 | FS_EPS_URACE | 40 | new; 23.736 | Chris Pudney | chris.pudney@vodafone.com | 79 |
| 41 | 38 | Study on physical layer enhancements for NR UR Low Latency Cases |  | 196d? | 2018-06-15 | 2019-03-15 |  |  | 26285d |  | finish no earlier than 2019-03-15 | R1 | 1568h |  | Rel-16 | FS_NR_L1enh_URLLC | 41 |  | Huawei |  | 80 |
| 42 | 39 | Study on NR Industrial Internet of Things (IoT) |  | 196d? | 2018-06-15 | 2019-03-15 |  |  | 26285d |  | finish no earlier than 2019-03-15 | R2 | 1568h |  | Rel-16 | FS_NR_IIOT | 41 | 38.825 | Nokia |  | 80 |
| 43 | 40 | Study on channel modeling for indoor industrial scenarios |  | 261d? | 2018-09-14 | 2019-09-13 |  |  | 26155d |  | finish no earlier than 2019-09-13 | R1 | 2088h |  | Rel-16 | FS_IIIOT_CM | 41 |  | Ericsson |  | 81 |
| 44 | 41 | 5GS Enhanced support of Vertical and LAN Services | milestone | 0d? | 2017-12-15 A | 2017-12-15 | 31% | 0d? | 26611d |  |  |  |  |  | Rel-16 |  |  |  |  |  |  |
| 45 | 42 | Study on Communication for Automation in Vertical Domains |  | 271d? | 2017-03-02 A | 2018-03-15 A | 100% |  |  |  | finish no earlier than 2018-03-15 | S1 | 2168h | 2168h | Rel-16 | FS_CAV | 38 | 22.804 | Walewski, Joachim, Siemens AG | joachim.walewski@siemens.com | 75 |
| 46 | 43 | Service requirements for cyber-physical control applications in vertical domains |  | 73d? | 2018-06-06 A | 2018-09-14 A | 100% |  |  |  | finish no earlier than 2018-09-14 | S1 | 584h | 584h | Rel-16 | cyberCAV | 41 | 22.261; 22.104 | Joachim W. Walewski (Siemens) |  | 80 |
| 47 | 44 | Study on 5GS Enhanced support of Vertical and LAN Services |  | 138d? | 2018-06-06 A | 2018-12-14 | 92% | 11.04d? | 26350d |  | finish no earlier than 2018-12-14 | S2 | 1104h | 276h | Rel-16 | FS_Vertical_LAN | 41 | 23.734 | Devaki Chandramouli, Nokia | Devaki.chandramouli@nokia.com | 80 |

Notes:
- 5: -
- 6: -
- 7: 4/12/18: 0%->15; 14/3/19: 15%->45
- 8: 4/12/18: 0%->15; 14/3/19: 15%->65
- 9: 14/3/19: 0%->5
- 12: 4/12/18: 0%->20; 14/3/19: 20%->70
- 13: -
- 14: 14/3/19: 0%->100
- 15: 7/3/19: 0%->5%
- 18: -
- 19: 4/12/18: 0%->20; 14/3/19: 20%->40
- 20: 6/8/18: 22.842 added;; 10/9/18: 0%->25; 4/12/18: 25%->60; 14/3/19: 60%->85
- 21: 6/8/18: 22.827 added;; 10/9/18: 0%->10; 4/12/18: 10%->50; 14/12/18: WID:SP-180340->SP-181015; 14/12/18: FCD:03/19->06/19; 14/3/19: 50%->80
- 23: 14/3/19: 0%->5
- 25: 16/3/18: 0%->10; 7/6/18: 10%->30; 10/9/18: 30%->50; 4/12/18: 50%->65; 12/12/18: FCD:03/19->09/19. Rel-16->Rel-17; 14/3/19: 65%->80
- 27: 14/3/19: 0%->5
- 34: -
- 35: -
- 36: 7/6/18: 0%->15; 6/8/18: 23.725 added;; 10/9/18: 15%->60; 7/12/18: 60%->85; 14/3/19: 85%->90
- 37: 14/3/19: 0%->50
- 38: 7/12/18: 0%->20
- 39: 16/3/18: 0%->35; 7/6/18: 35%->75
- 40: 7/6/18: 0%->10; 6/8/18: 23.736 added;
- 41: TR 38.8xx
- 42: TR 38.8XX?; 6/8/18: 38.825 added;
- 44: -
- 45: 7/6/17: 0%->30; 25/8/17: FCD:12/17->03/18; 11/9/17: 30%->65; 15/12/17: 65%->85; 16/3/18: 85%->95; 7/6/18: 95%->100
- 46: 10/9/18: 5%->40; 4/12/18: 40%->100
- 47: 10/9/18: 0%->25; 7/12/18: 25%->88; 14/3/19: 88%->92

| ID | WBS | Task | Type | Duration | Start | Finish | Complete | Remaining | Total slack | Constraint | Resources | Work | Actual work | Acronym | WI rapporteur name | WI rapporteur e-mail | Release | TSG approved | PCG approved |
| --- | --- | --- | --- | --- | --- | --- | --- | --- | --- | --- | --- | --- | --- | --- | --- | --- | --- | --- | --- |
| 48 | 45 | **5GS Enhanced support of Vertical and LAN Services** |  | 261d | 2018-12-13 A | 2019-12-12 | 8% | 239.67d | 26091d |  | S2 | 9464h | 170.66h | Vertical_LAN | Devaki Chandramouli, Nokia | Devaki.chandramouli@nokia.com | Rel-16 | 82 |  |
| 49 | 45.1 | Stage 2 of Vertical_LAN |  | 138d | 2018-12-13 A | 2019-06-24 | 43% | 78.66d | 26214d | start no earlier than 2018-12-13 | S2 | 1104h |  | Vertical_LAN | Devaki Chandramouli, Nokia | Devaki.chandramouli@nokia.com | Rel-16 | 82 |  |
| 50 | 45.2 | **CT aspects of Vertical_LAN** |  | 196d | 2019-03-14 | 2019-12-12 |  |  | 26091d |  | ct | 6272h |  | Vertical_LAN | WON, Sung Hwan, Nokia | sung.won@nokia.com | Rel-16 |  |  |
| 51 | 45.2.1 | CT1 aspects of Vertical_LAN |  | 196d | 2019-03-14 | 2019-12-12 |  |  | 26091d | start no earlier than 2019-03-14 | C1 | 1568h |  | Vertical_LAN | WON, Sung Hwan, Nokia | sung.won@nokia.com | Rel-16 |  |  |
| 52 | 45.2.2 | CT3 aspects of Vertical_LAN |  | 196d | 2019-03-14 | 2019-12-12 |  |  | 26091d | start no earlier than 2019-03-14 | C3 | 1568h |  | Vertical_LAN | WON, Sung Hwan, Nokia | sung.won@nokia.com | Rel-16 |  |  |
| 53 | 45.2.3 | CT4 aspects of Vertical_LAN |  | 196d | 2019-03-14 | 2019-12-12 |  |  | 26091d | start no earlier than 2019-03-14 | C4 | 1568h |  | Vertical_LAN | WON, Sung Hwan, Nokia | sung.won@nokia.com | Rel-16 |  |  |
| 54 | 46 | Service Enabler Architecture Layer for Verticals |  | 136d | 2018-12-06 A | 2019-06-13 | 60% | 54.4d | 26221d | start no earlier than 2018-12-06 | S6 | 1088h |  | SEAL | Basavaraj (Basu) Pattan, Samsung | basavarajjp@samsung.com | Rel-16 | 82 |  |
| 55 | 47 | Study on Security for 5GS Enhanced support of Vertical and LAN Services |  | 137d? | 2018-09-06 A | 2019-03-15 | 10% | 123.3d? | 26285d | finish no earlier than 2019-03-15 | S3 | 1096h |  | FS_Vertical_LAN_SEC | Jerichow, Anja (Nokia) | anja.jerichow@nokia.com | Rel-16 | 81 | 41 |
| 56 | 48 | **NR-based access to unlicensed spectrum** |  | 5629d | 2098-05-20 | 2119-12-15 | 47% |  |  |  | R1 | 52888h | 3664h | NR_unlic | Qualcomm |  | Rel-16 | 82 |  |
| 57 | 48.1 | Study on NR-based access to unlicensed spectrum |  | 458d? | 2017-03-15 A | 2018-12-14 A | 100% |  |  | finish no earlier than 2018-12-15 | R1 | 3664h | 3664h | FS_NR_unlic | Qualcomm |  | Rel-16 | 75 | 38 |
| 58 | 48.2 | Core part: NR-based access to unlicensed spectrum | manual | 262d | 2018-12-15 | 2019-12-15 |  |  |  |  | R1 | 2096h |  | NR_unlic-Core | Qualcomm |  | Rel-16 | 82 |  |
| 59 | 48.3 | Perf. part: NR-based access to unlicensed spectrum | manual | 262d | 2018-12-15 | 2019-12-15 |  |  |  |  | R4 | 2096h |  | NR_unlic-Perf | Qualcomm |  | Rel-16 | 82 |  |
| 60 | 49 | **LAN support in 5G** |  | 400d? | 2017-06-05 A | 2018-12-14 | 99% | 0d? | 0d |  | S1 | 4304h | 4299.43h | 5GLAN | Almodovar Chico, Jose Luis, KPN | jose.almodovarchico@tno.nl | Rel-16 | 80 | 41 |
| 61 | 49.1 | Study on LAN Support in 5G |  | 204d? | 2017-06-05 A | 2018-03-15 A | 100% |  |  | finish no earlier than 2018-03-15 | S1 | 1632h | 1632h | FS_5GLAN | Nasielski, Jack, Qualcomm Incorporated | jackn@qti.qualcomm.com | Rel-16 | 76 | 39 |
| 62 | 49.2 | Stage 1 of 5GLAN |  | 138d? | 2018-06-06 A | 2018-12-14 A | 100% |  |  | finish no earlier than 2018-12-14 | S1 | 1104h | 1104h | 5GLAN | Almodovar Chico, Jose Luis, KPN | jose.almodovarchico@tno.nl | Rel-16 | 80 | 41 |
| 63 | 50 | Study on non-public networks management |  | 195.88d | 2019-03-07 | 2019-12-05 |  |  | 26096d |  | S5 | 1567h |  | FS_OAM_NPN | ZHANG, Kai, Huawei | kai.zhangkai@huawei.com | Rel-16 |  |  |
| 64 | 51 | Cellular IoT support and evolution | milestone | 0d? | 2016-06-18 A | 2016-06-18 | 17% | 0d? | 27000.2d |  |  |  |  |  |  |  | Rel-16 |  |  |
| 65 | 52 | Study on Cellular IoT support and evolution for the 5G System |  | 331d? | 2017-09-08 A | 2018-12-14 | 95% | 16.55d? | 26350d | finish no earlier than 2018-12-14 | S2 | 2648h | 1853.6h | FS_CIoT_5G | Sebastian Speicher | sspeiche@qti.qualcomm.com | Rel-16 | 77 | 39 |
| 66 | 53 | **Cellular IoT support and evolution for the 5G System** |  | 261d | 2018-12-13 A | 2019-12-12 | 7% | 241.71d | 26091d |  | S2 | 11016h | 154.33h | 5G_CIoT |  |  | Rel-16 |  |  |
| 67 | 53.1 | Stage 2 of 5G_CIoT |  | 136d | 2018-12-13 A | 2019-06-20 | 50% | 68d | 26216d | start no earlier than 2018-12-13 | S2 | 1088h |  | 5G_CIoT | Sebastian Speicher | sspeiche@qti.qualcomm.com | Rel-16 | 82 |  |
| 68 | 53.2 | **CT aspects of 5G_CIoT** |  | 196d | 2019-03-14 | 2019-12-12 |  |  | 26091d |  | ct | 7840h |  | 5G_CIoT | Mahmoud Watfa; Qualcomm Incorporated | mwatfa@qti.qualcomm.com | Rel-16 |  |  |
| 69 | 53.2.1 | CT1 aspects of 5G_CIoT |  | 196d | 2019-03-14 | 2019-12-12 |  |  | 26091d | start no earlier than 2019-03-14 | C1 | 1568h |  | 5G_CIoT | Mahmoud Watfa; Qualcomm Incorporated | mwatfa@qti.qualcomm.com | Rel-16 |  |  |
| 70 | 53.2.2 | CT3 aspects of 5G_CIoT |  | 196d | 2019-03-14 | 2019-12-12 |  |  | 26091d | start no earlier than 2019-03-14 | C3 | 1568h |  | 5G_CIoT | Mahmoud Watfa; Qualcomm Incorporated | mwatfa@qti.qualcomm.com | Rel-16 |  |  |
| 71 | 53.2.3 | CT4 aspects of 5G_CIoT |  | 196d | 2019-03-14 | 2019-12-12 |  |  | 26091d | start no earlier than 2019-03-14 | C4 | 1568h |  | 5G_CIoT | Mahmoud Watfa; Qualcomm Incorporated | mwatfa@qti.qualcomm.com | Rel-16 |  |  |
| 72 | 53.2.4 | CT6 aspects of 5G_CIoT |  | 196d | 2019-03-14 | 2019-12-12 |  |  | 26091d | start no earlier than 2019-03-14 | C6 | 1568h |  | 5G_CIoT | Mahmoud Watfa; Qualcomm Incorporated | mwatfa@qti.qualcomm.com | Rel-16 |  |  |
| 73 | 54 | Study on evolution of Cellular IoT security for the 5G System |  | 202d? | 2018-06-06 A | 2019-03-14 | 30% | 141.4d? | 26286d | finish no earlier than 2019-03-14 | S3 | 1616h | 80.8h | FS_CIoT_sec_5G | Noamen Ben Henda | noamen.ben.henda@ericsson.com | Rel-16 | 80 | 41 |
| 74 | 55 | Study on MBMS User Services for IoT |  | 335d? | 2017-06-05 A | 2018-09-14 A | 100% |  |  | finish no earlier than 2018-09-14 | S4 | 2680h | 2680h | FS_MBMS_IoT | Cedric thienot, Expway | cedric (dot) thienot (at) expway (dot) com | Rel-16 | 76 | 39 |

Notes:
- 49: 14/3/19: 0%->43 / Impacted TSs and TRs: 23.501; 23.502; 23.503
- 51: Impacted TSs and TRs: 23.122; 24.368; 24.501; 24.526
- 52: Impacted TSs and TRs: 29.122; 29.507; 29.508; 29.512; 29.513; 29.514; 29.519; 29.520; 29.521; 29.522; 29.523; 29.525; 29.554; 29.561; 29.594; 29.061
- 53: Impacted TSs and TRs: 23.003; 23.008; 29.502; 29.503; 29.505; 29.509; 29.510; 29.518; 29.571; 29.244; 29.281
- 54: 14/3/19: 0%->60 / Impacted TSs and TRs: new 23.434
- 55: 7/12/18: 0%->10 / Impacted TSs and TRs: New
- 57: TR 38.8XX19/6/17: WID: RP-170828->RP-171416; 30/6/17: 32.889 added;; 19/9/17: WID: RP-171416->RP-17202127/3/18: Compl:0%->10%; 27/6/18: Compl:10%->40%; 27/6/18: CD:Fri 15/06/18->Sat 15/12/18; 16/1/19: 40%->100 / Impacted TSs and TRs: 32.889
- 60: Impacted TSs and TRs: 22.261; 22.278
- 61: 11/9/17: 0%->35; 15/12/17: 35%->65; 16/3/18: 65%->100 / Impacted TSs and TRs: 22.821;
- 62: 10/9/18: 40%->75; 10/9/18: FCD:09/18->12/18; 4/12/18: 75%->100 / Impacted TSs and TRs: 22.261; 22.278
- 63: Impacted TSs and TRs: New
- 64: -
- 65: 11/09/17: rapporteur change; 15/12/17: 23.724 added;; 16/3/18: 0%->20; 7/6/18: 20%->50; 15/6/18: WID:SP-170801->SP-180614; 15/6/18: FCD:09/18->12/18; 10/9/18: 50%->70; 7/12/18: 70%->95 / Impacted TSs and TRs: New; 23.724
- 67: 14/3/19: 0%->50 / Impacted TSs and TRs: 23.501; 23.502
- 69: Impacted TSs and TRs: 23.122; 24.250; 24.301; 24.368; 24.501; 27.007
- 70: Impacted TSs and TRs: 29.122; 29.522; 29.525; 29.222; 29.512; 29.513; 29.514
- 71: Impacted TSs and TRs: 23.008; 29.274; 29.502; 29.503; 29.505; 29.518
- 72: Impacted TSs and TRs: 31.102; 31.111
- 73: 6/8/18: 33.861 added;; 7/12/18: 5%->30 / Impacted TSs and TRs: New; 33.861
- 74: 11/9/17: 0%->10; 15/12/17: 10%->30; 16/3/18: 30%->80; 16/3/18: FCD:03/18->06/18; 7/6/18: 80%->90; 7/6/18: FCD:06/18->09/18. 14/06/18: Moved from Rel-15; 10/9/18: 90%->100 / Impacted TSs and TRs: 26.8xx

| ID | WBS | Task | Type | Duration | Start | Finish | Complete | Remaining | Total slack | Constraint | Resources | Work | Actual work | Acronym | PCG approved | WI rapporteur name | Release | TSG approved | Impacted TSs and TRs | WI rapporteur e-mail | Status Report |
| --- | --- | --- | --- | --- | --- | --- | --- | --- | --- | --- | --- | --- | --- | --- | --- | --- | --- | --- | --- | --- | --- |
| 75 | 56 | **Additional MTC enhancements for LTE** |  | 522d? | 2018-06-15 | 2020-06-15 |  |  | 25959d |  | R1 | 11480h |  | LTE_eMTC5 | 41 | Ericsson | Rel-16 | 80 |  |  |  |
| 76 | 56.1 | Core part: Additional MTC enhancements for LTE |  | 391d? | 2018-06-15 | 2019-12-15 |  |  | 26090d | finish no earlier than 2019-12-15 | R1 | 3128h |  | LTE_eMTC5-Core | 41 | Ericsson | Rel-16 | 80 |  |  |  |
| 77 | 56.2 | Perf. part: Additional MTC enhancements for LTE |  | 522d? | 2018-06-15 | 2020-06-15 |  |  | 25959d | finish no earlier than 2020-06-15 | R4 | 4176h |  | LTE_eMTC5-Perf | 41 | Ericsson | Rel-16 | 80 |  |  |  |
| 78 | 57 | **Additional enhancements for NB-IoT** |  | 522d? | 2018-06-15 | 2020-06-15 |  |  | 25959d |  | R1 | 11480h |  | NB_IOTenh3 | 41 | Huawei | Rel-16 | 80 |  |  |  |
| 79 | 57.1 | Core part: Additional enhancements for NB-IoT |  | 391d? | 2018-06-15 | 2019-12-15 |  |  | 26090d | finish no earlier than 2019-12-15 | R1 | 3128h |  | NB_IOTenh3-Core | 41 | Huawei | Rel-16 | 80 |  |  |  |
| 80 | 57.2 | Perf. part: Additional enhancements for NB-IoT |  | 522d? | 2018-06-15 | 2020-06-15 |  |  | 25959d | finish no earlier than 2020-06-15 | R4 | 4176h |  | NB_IOTenh3-Perf | 41 | Huawei | Rel-16 | 80 |  |  |  |
| 81 | 58 | **5G message service** |  | 650.2d? | 2016-06-18 A | 2018-12-14 A | 100% |  |  |  | S1 | 7905.6h | 7905.6h | 5GMSG | 41 |  | Rel-16 | 81 | 22.262 |  |  |
| 82 | 58.1 | Study on 5G message service for MIoT |  | 266d? | 2016-06-18 A | 2018-09-14 A | 100% |  |  | finish no earlier than 2018-09-14 | S1 | 2128h | 2128h | FS_5GMSG | 39 | Zheng, Jianping, China Mobile | Rel-16 | 77 | New; 22.824 | zhengjianping@chinamobile.com |  |
| 83 | 58.2 | Message Service Within the 5G System requirements |  | 72d? | 2018-09-06 A | 2018-12-14 A | 100% |  |  | finish no earlier than 2018-12-14 | S1 | 576h | 576h | MSGin5G | 41 | Zheng, Jianping, China Mobile | Rel-16 | 81 | 22.262; 22.261 | zhengjianping@chinamobile.com |  |
| 84 | 59 | Advanced V2X support | milestone | 0d? | 2017-06-05 A | 2017-06-05 | 45% | 0d? | 26750d |  |  |  |  |  |  |  | Rel-16 |  |  |  |  |
| 85 | 60 | Study on Improvement of V2X Service Handling |  | 66d? | 2018-03-15 A | 2018-06-14 A | 100% |  |  | finish no earlier than 2018-06-14 | S1 | 528h | 528h | FS_V2XIMP | 40 | SungDuck Chun; LG Electronics | Rel-16 | 79 | 22.886 | sungduck.chun@lge.com |  |
| 86 | 61 | Improvement of V2X service Handling |  | 29d | 2018-10-25 A | 2018-12-04 A | 100% |  |  | finish no earlier than 2018-12-04 | S1 | 232h | 232h | V2XIMP |  | SungDuck Chun; LG Electronics | Rel-16 | 82 | 22.186 | sungduck.chun@lge.com |  |
| 87 | 62 | Study on application layer support for V2X services |  | 196d? | 2017-12-15 A | 2018-09-14 A | 100% |  |  | finish no earlier than 2018-09-14 | S6 | 1568h | 1568h | FS_V2XAPP | 40 | Niranth Amogh, Huawei Telecommunications India | Rel-16 | 78 |  | namogh@huawei.com |  |
| 88 | 63 | Application layer support for V2X services |  | 202d? | 2018-09-06 A | 2019-06-14 | 65% | 70.7d? | 26220d | finish no earlier than 2019-06-14 | S6 | 1616h |  | V2XAPP | 41 | Niranth Amogh, Huawei Telecommunications India | Rel-16 | 81 | New | namogh@huawei.com |  |
| 89 | 64 | Study on architecture enhancements for 3GPP support of advanced V2X services |  | 400d? | 2017-06-05 A | 2018-12-14 | 95% | 20d? | 26350d | finish no earlier than 2018-12-14 | S2 | 3200h | 1856h | FS_eV2XARC | 39 | LaeYoung Kim, LG Electronics | Rel-16 | 76 | 23.786 | laeyoung.kim@lge.com | SP-170412 |
| 90 | 65 | Architecture enhancements for 3GPP support of advanced V2X services |  | 400d | 2018-12-13 A | 2020-06-24 | 30% | 280d | 25952d | start no earlier than 2018-12-13 | S2 | 3200h |  | eV2XARC |  | LaeYoung Kim, LG Electronics | Rel-16 | 82 | 23.501; 23.502; 23.503; 23.285 | laeyoung.kim@lge.com |  |
| 91 | 66 | Study on NR Vehicle-to-Everything (V2X) |  | 196d? | 2018-06-15 | 2019-03-15 |  |  | 26285d | finish no earlier than 2019-03-15 | R1 | 1568h |  | FS_NR_V2X | 41 | LG Electronics | Rel-16 | 80 |  |  |  |
| 92 | 67 | Study on V2X Media Handling and Interaction |  | 525d? | 2017-09-08 A | 2019-09-12 | 70% | 157.5d? | 26156d | finish no earlier than 2019-09-12 | S4 | 4200h | 2118.4h | FS_mV2X | 39 | Jung, Kyunghun, Samsung Electronics Co., Ltd | Rel-16 | 77 | New; 26.985 | kyunghun.jung@samsung.com |  |
| 93 | 68 | Study on Security Aspects of 3GPP support for Advanced V2X Services |  | 130.88d | 2019-03-07 | 2019-09-05 |  |  | 26161d |  | S3 | 1047h |  | FS_eV2X_Sec |  | Joonwoong Kim, LG Electronics | Rel-16 |  | New | joonwoong.kim@lge.com |  |
| 94 | 69 | 5G Location and Positionning Services | milestone | 0d? | 2017-06-05 A | 2017-06-05 | 56% | 0d? | 26750d |  |  |  |  |  |  |  | Rel-16 |  |  |  |  |
| 95 | 70 | **5G positioning services** |  | 400d? | 2017-06-05 A | 2018-12-14 A | 100% |  |  |  | S1 | 6464h | 6464h | 5G_HYPOS | 41 | Ries, Lionel, ESA | Rel-16 | 80 | 22.261 | lionel.ries at esa.int |  |
| 96 | 70.1 | Study on positioning use cases |  | 270d? | 2017-06-05 A | 2018-06-15 A | 100% |  |  | finish no earlier than 2018-06-15 | S1 | 2160h | 2160h | FS_5G_HYPOS | 39 | Ries, Lionel, ESA | Rel-16 | 76 | 22.872 | lionel.ries@esa.int |  |
| 97 | 70.2 | Stage 1 of 5G_HYPOS |  | 138d? | 2018-06-06 A | 2018-12-14 A | 100% |  |  | finish no earlier than 2018-12-14 | S1 | 1104h | 1104h | 5G_HYPOS | 41 | Ries, Lionel, ESA | Rel-16 | 80 | 22.261 | lionel.ries at esa.int |  |
| 98 | 71 | Study on Enhancement to the 5GC Location Services |  | 325d? | 2017-12-15 A | 2019-03-14 A | 100% |  |  | finish no earlier than 2019-03-14 | S2 | 2600h | 2600h | FS_eLCS | 40 | Ming Ai, CATT | Rel-16 | 78 | new 23.731 | aiming@catt.cn |  |

Notes:
- 75: RAN3 impact?; 16/1/19: WID:RP-181450->RP-182891
- 76: RAN3 impact?
- 78: RAN3 impact?; 16/1/19: WID:RP-181451->RP-182902
- 79: RAN3 impact?
- 82: 15/12/17: 22.824 added;; 15/12/17: 0%->25; 16/3/18: 25%->60; 10/9/18: 60%->95; 4/12/18: 95%->100
- 83: 4/12/18: 0%->100
- 84: -
- 85: 7/6/18: 0%->75; 10/9/18: 75%->95; 4/12/18: 95%->100
- 86: 4/12/18: 0%->95; 14/3/19: 95%->100
- 87: 16/3/18: 0%->45; 14/6/18: 45%->75; 10/9/18: 75%->95; 7/12/18: 95%->100
- 88: 7/12/18: 0%->25; 14/3/19: 25%->65
- 89: 11/9/17: 0%->20; 15/12/17: Changed Rel-15->Rel-16; 16/3/18: WID:SP-170379->SP 170590; 16/3/18: 20%->25; 7/6/18: 25%->35; 10/9/18: 35%->58; 10/9/18: FCD:09/18->12/18; 2/10/18: WID:SP 170590->SP-180733; 7/12/18: 58%->88; 14/3/19: 88%->95
- 90: 14/3/19: 0%->30
- 91: TR 38.8XX; compare SA1 REL-15 SI FS_eV2X, RAN1 REL-15 SI FS_LTE_NR_V2X_eval, SA2 REL-16 SI FS_eV2XARC, SA1 REL-16 SI FS_V2XIMP
- 92: 15/12/17: 26.985 added;; 15/12/17: 0%->30; 16/3/18: 30%->50; 22/3/18: FCD:09/18->12/18; 7/6/18: 50%->60. 14/06/18: Moved from Rel-15; 10/9/18: 60%->80; 13/12/18: 80%->60; 13/12/18: FCD:12/18->09/19; 12/3/19: 60%->70
- 94: -
- 96: 11/9/17: 0%->10; 15/12/17: 10%->50; 15/12/17: FCD:03/18->06/18; 16/3/18: 50%->75; 7/6/18: 75%->90; 10/9/18: 90%->100
- 97: 10/9/18: 0%->50; 10/9/18: FCD:09/18->12/18; 4/12/18: 50%->100
- 98: 16/3/18: 0%->15; 7/6/18: 15%->45; 10/9/18: 45%->55; 10/9/18: FCD:12/18->03/19; 2/10/18: WID:SP-170937->SP-180734; 7/12/18: 55%->100

| ID | WBS | Task | Type | Duration | Start | Finish | Complete | Remaining | Total slack | Constraint | Resources | Work | Actual work | Acronym | Impacted TSs and TRs | WI rapporteur name | WI rapporteur e-mail | Release | TSG approved | PCG approved |
| --- | --- | --- | --- | --- | --- | --- | --- | --- | --- | --- | --- | --- | --- | --- | --- | --- | --- | --- | --- | --- |
| 99 | 72 | **Enhancement to the 5GC LoCation Services** |  | 256d | 2018-12-13 A | 2019-12-05 | 8% | 234.36d | 26096d |  | S2 | 9408h | 173.12h | 5G_eLCS | 23.501; 23.502 | Ming Ai, CATT | aiming@catt.cn | Rel-16 | 82 |  |
| 100 | 72.1 | Stage 2 of 5G_eLCS |  | 136d | 2018-12-13 A | 2019-06-20 | 45% | 74.8d | 26216d | start no earlier than 2018-12-13 | S2 | 1088h |  | 5G_eLCS | 23.501; 23.502 | Ming Ai, CATT | aiming@catt.cn | Rel-16 | 82 |  |
| 101 | 72.2 | **CT aspects of 5G_eLCS** |  | 196d | 2019-03-07 | 2019-12-05 |  |  | 26096d |  | ct | 6272h |  | 5G_eLCS |  | Tingfang Tang, CATT | tangtingfang@catt.cn | Rel-16 |  |  |
| 102 | 72.2.1 | CT1 aspects of 5G_eLCS |  | 196d | 2019-03-07 | 2019-12-05 |  |  | 26096d | start no earlier than 2019-03-07 | C1 | 1568h |  | 5G_eLCS | 24.501; 27.007 | Tingfang Tang, CATT | tangtingfang@catt.cn | Rel-16 |  |  |
| 103 | 72.2.2 | CT3 aspects of 5G_eLCS |  | 196d | 2019-03-07 | 2019-12-05 |  |  | 26096d | start no earlier than 2019-03-07 | C3 | 1568h |  | 5G_eLCS | 29.522; 29.122 | Tingfang Tang, CATT | tangtingfang@catt.cn | Rel-16 |  |  |
| 104 | 72.2.3 | CT4 aspects of 5G_eLCS |  | 196d | 2019-03-07 | 2019-12-05 |  |  | 26096d | start no earlier than 2019-03-07 | C4 | 1568h |  | 5G_eLCS | 24.080; 29.518; 29.572; 29.503; 29.505 | Tingfang Tang, CATT | tangtingfang@catt.cn | Rel-16 |  |  |
| 105 | 73 | Study on Security of the enhancement to the 5GC location services |  | 332d? | 2018-09-06 A | 2019-12-13 | 5% | 315.4d? | 26090d | finish no earlier than 2019-12-13 | S3 | 2656h |  | FS_eLCS_Sec | New | Wei Zhou, CATT | zhouwei@catt.cn | Rel-16 | 81 | 41 |
| 106 | 74 | Study on NR positioning support |  | 196d? | 2018-06-15 | 2019-03-15 |  |  | 26285d | finish no earlier than 2019-03-15 | R1 | 1568h |  | FS_NR_pos |  | Intel |  | Rel-16 | 80 | 41 |
| 107 | 75 | UE radio capability signalling optimization | milestone | 0d? | 2018-06-06 A | 2018-06-06 | 17% | 0d? | 26488d |  |  |  |  |  |  |  |  | Rel-16 |  |  |
| 108 | 76 | Study on optimisations on UE radio capability signalling |  | 138d? | 2018-06-06 A | 2018-12-14 A | 100% |  |  | finish no earlier than 2018-12-14 | S2 | 1104h | 1104h | FS_RACS | New | Haris Zisimopoulos, Qualcomm Incorporated | harisz@qti.qualcomm.com | Rel-16 | 80 | 41 |
| 109 | 77 | Optimisations on UE radio capability signalling |  | 65.88d | 2019-03-07 | 2019-06-06 |  |  | 26226d |  | S2 | 527h |  | RACS | 23.501; 23.502; 23.401 | Haris Zisimopoulos | harisz@qti.qualcomm.com | Rel-16 |  |  |
| 110 | 78 | Study on optimisations on UE radio capability signalling – NR/E-UTRA Aspects |  | 196d? | 2018-06-15 | 2019-03-15 |  |  | 26285d | finish no earlier than 2019-03-15 | R2 | 1568h |  | FS_RACS_RAN | 37.873 | MediaTek |  | Rel-16 | 80 | 41 |
| 111 | 79 | Satellite Access in 5G | milestone | 0d? | 2017-09-08 A | 2017-09-08 | 35% | 0d? | 26681d |  |  |  |  |  |  |  |  | Rel-16 |  |  |
| 112 | 80 | **Integration of Satellite Access in 5G** |  | 266d? | 2017-09-08 A | 2018-09-14 A | 100% |  |  |  | S1 | 4320h | 4320h | 5GSAT | 22.261 | MICHEL, Cyril, Thales | cyril.michel@thalesaleniaspace.com | Rel-16 | 80 | 41 |
| 113 | 80.1 | Study on using Satellite Access in 5G |  | 201d? | 2017-09-08 A | 2018-06-15 A | 100% |  |  | finish no earlier than 2018-06-15 | S1 | 1608h | 1608h | FS_5GSAT | New; 22.822 | MICHEL, Cyril | cyril.michel@thalesaleniaspace.com | Rel-16 | 77 | 39 |
| 114 | 80.2 | Stage 1 of 5GSAT |  | 73d? | 2018-06-06 A | 2018-09-14 A | 100% |  |  | finish no earlier than 2018-09-14 | S1 | 584h | 584h | 5GSAT | 22.261 | MICHEL, Cyril, Thales | cyril.michel@thalesaleniaspace.com | Rel-16 | 80 | 41 |
| 115 | 81 | Study on architecture aspects for using satellite access in 5G |  | 332d? | 2018-06-06 A | 2019-09-12 | 50% | 166d? | 26156d | finish no earlier than 2019-09-12 | S2 | 2656h | 242.4h | FS_5GSAT_ARCH | New | MICHEL, Cyril | cyril.michel@thalesaleniaspace.com | Rel-16 | 80 | 41 |
| 116 | 82 | Study on solutions for NR to support non-terrestrial networks (NTN) |  | 391d? | 2018-06-15 | 2019-12-15 |  |  | 26090d | finish no earlier than 2019-12-15 | R3 | 3128h |  | FS_NR_NTN_solutions |  | Thales |  | Rel-16 | 80 | 41 |
| 117 | 83 | Study on management and orchestration aspects with integrated satellite components in a 5G network | manual | 195.88d | 2019-03-14 | 2019-12-12 |  |  |  |  | S5 | 1567h |  | FS_5GSAT_MO | New | MICHEL, Cyril, THALES | cyril.michel@thalesaleniaspace.com | Rel-16 |  |  |
| 118 | 84 | Enablers for Network Automation Architecture for 5G |  | 1d? | 2017-06-05 A | 2017-06-05 A | 100% |  |  | finish no earlier than 2017-06-05 |  |  |  |  |  |  |  | Rel-16 |  |  |
| 119 | 85 | Study of enablers for Network Automation for 5G |  | 400d? | 2017-06-05 A | 2018-12-14 | 94% | 24d? | 26350d | finish no earlier than 2018-12-14 | S2 | 3200h | 1600h | FS_eNA | new 23.791 | Xiaobo Wu, Huawei Technologies | wuxiaobo@huawei.com | Rel-16 | 76 | 39 |
| 120 | 86 | **Enablers for Network Automation for 5G** |  | 261d | 2018-12-06 A | 2019-12-05 | 13% | 227.02d | 26096d |  | S2 | 7896h | 271.83h | eNA | 23.501; 23.502; 23.503 | Xiaobo Wu, Huawei Technologies | wuxiaobo@huawei.com | Rel-16 | 82 |  |
| 121 | 86.1 | Stage 2 of eNA |  | 138d | 2018-12-06 A | 2019-06-17 | 50% | 69d | 26219d | start no earlier than 2018-12-06 | S2 | 1104h |  | eNA | 23.501; 23.502; 23.503 | Xiaobo Wu, Huawei Technologies | wuxiaobo@huawei.com | Rel-16 | 82 |  |
| 122 | 86.2 | **CT aspects of eNA** |  | 196d | 2019-03-07 | 2019-12-05 |  |  | 26096d |  | ct | 4704h |  | eNA |  | Yali Yan, Huawei | yanyali@huawei.com | Rel-16 | 82 |  |
| 123 | 86.2.1 | CT3 aspects of eNA |  | 196d | 2019-03-07 | 2019-12-05 |  |  | 26096d |  | C3 | 1568h |  | eNA | 29.122; 29.508; 29.514; 29.520; 29.522; 29.523; 29.554 | Yali Yan, Huawei | yanyali@huawei.com | Rel-16 | 82 |  |
| 124 | 86.2.2 | CT4 aspects of eNA |  | 196d | 2019-03-07 | 2019-12-05 |  |  | 26096d |  | C4 | 1568h |  | eNA | 29.244; 29.510; 29.518; 29.503; 29.505 | Yali Yan, Huawei | yanyali@huawei.com | Rel-16 | 82 |  |
| 125 | 87 | Wireless and Wireline Convergence Enhancement | milestone | 0d? | 2017-06-05 A | 2017-06-05 A | 100% |  |  |  |  |  |  |  |  |  |  | Rel-16 |  |  |
| 126 | 88 | Study on the Wireless and Wireline Convergence for the 5G system architecture |  | 400d? | 2017-06-05 A | 2018-12-14 A | 100% |  |  | finish no earlier than 2018-12-14 | S2 | 3200h | 3200h | FS_5WWC | 23.716 | Marco Spini, Huawei Technologies | m.spini@huawei.com | Rel-16 | 76 | 39 |
| 127 | 89 | Study on the security of the Wireless and Wireline Convergence for the 5G system architecture |  | 202d? | 2018-06-06 A | 2019-03-14 | 30% | 141.4d? | 26286d | finish no earlier than 2019-03-14 | S3 | 1616h | 80.8h | FS_5WWC_SEC | New; 33.807 | He Li, Huawei Technologies | LIHE2@HUAWEI.COM | Rel-16 | 80 | 41 |

Notes:
- 100: 14/3/19: 0%->45
- 105: 7/12/18: 0%->5
- 106: TR 38.8xx
- 107: -
- 108: 10/9/18: 0%->40; 7/12/18: 40%->70; 14/3/19: 70%->100
- 110: TR 37.8xx; related SA2 SI FS_RACS was started at SA #80 ; 6/8/18: 37.873 added;
- 111: -
- 113: 15/12/17: 22.822 added;; 15/12/17: 0%->30; 15/12/17: FCD:12/17->06/18; 16/3/18: 30%->70; 7/6/18: 70%->100
- 114: 10/9/18: 0%->95; 4/12/18: 95%->100
- 115: 10/9/18: 0%->15; 10/9/18: FCD:06/19->03/19; 7/12/18: 15%->35; 14/12/18: WID:SP-180505->SP-181253; 14/12/18: FCD:03/19->09/19; 14/3/19: 35%->50
- 116: TR 38.8xx; compare REL-15 SI FS_NR_nonterr_nw
- 118: -
- 119: 16/3/18: FCD:09/18->06/18; 16/3/18: 0%->15; 7/6/18: 15%->30; 15/6/18: WID:SP-170383->SP-180613; 15/6/18: FCD:06/18->09/18; 10/9/18: 30%->50; 10/9/18: FCD:09/18->12/18; 2/10/18: WID:SP-180613->SP-180792; 7/12/18: 50%->90; 14/3/19: 90%->94
- 121: 14/3/19: 0%->50
- 125: -
- 126: 11/9/17: 0%->15; 15/12/17: Changed Rel-15->Rel-16; 16/3/18: 15%->25; 7/6/18: 25%->35; 10/9/18: 35%->60; 10/9/18: FCD:06/18->12/18; 7/12/18: 60%->100
- 127: 6/8/18: 33.807 added;; 10/9/18: 0%->5; 7/12/18: 5%->30

| ID | WBS | Task | Duration | Start | Finish | Complete | Remaining | Total slack | Constraint | Resources | Work | Actual work | Acronym | WI rapporteur name | WI rapporteur e-mail | Release | TSG approved | PCG approved |
| --- | --- | --- | --- | --- | --- | --- | --- | --- | --- | --- | --- | --- | --- | --- | --- | --- | --- | --- |
| 128 | 90 | **Wireless and Wireline Convergence for the 5G system architecture** | 261d | 2018-12-06 A | 2019-12-05 | 9% | 236.49d | 26096d |  |  | 7360h |  | 5WWC | Marco Spini, Huawei Technologies | m.spini@huawei.com | Rel-16 | 82 |  |
| 129 | 90.1 | Stage 2 of 5WWC | 136d | 2018-12-06 A | 2019-06-13 | 50% | 68d | 26221d |  | S2 | 1088h |  | 5WWC | Marco Spini, Huawei Technologies | m.spini@huawei.com | Rel-16 | 82 |  |
| 130 | 90.2 | **CT aspects of 5WWC** | 196d | 2019-03-07 | 2019-12-05 |  |  | 26096d |  | ct | 6272h |  | 5WWC | Herrero Veron, Christian (Huawei) | Christian.Herrero at huawei.com | Rel-16 |  |  |
| 131 | 90.2.1 | CT1 aspects of 5WWC | 196d | 2019-03-07 | 2019-12-05 |  |  | 26096d |  | C1 | 1568h |  | 5WWC | Herrero Veron, Christian (Huawei) | Christian.Herrero at huawei.com | Rel-16 |  |  |
| 132 | 90.2.2 | CT3 aspects of 5WWC | 196d | 2019-03-07 | 2019-12-05 |  |  | 26096d |  | C3 | 1568h |  | 5WWC | Herrero Veron, Christian (Huawei) | Christian.Herrero at huawei.com | Rel-16 |  |  |
| 133 | 90.2.3 | CT4 aspects of 5WWC | 196d | 2019-03-07 | 2019-12-05 |  |  | 26096d |  | C4 | 1568h |  | 5WWC | Herrero Veron, Christian (Huawei) | Christian.Herrero at huawei.com | Rel-16 |  |  |
| 134 | 91 | Mission Critical, Public Warning, Railways and Maritime | 1d? | 2016-09-19 A | 2016-09-19 A | 100% |  |  |  |  |  |  |  |  |  | Rel-16 |  |  |
| 135 | 92 | Study on MC services access aspects | 325d? | 2018-03-15 A | 2019-06-12 | 75% | 81.25d? | 26222d | finish no earlier than 2019-06-12 | S6 | 2600h | 522h | FS_MCSAA | Joakim Åkesson, Ericsson | Joakim.akesson@ericsson.com | Rel-16 | 79 | 40 |
| 136 | 93 | Study into discreet listening and logging for mission critical services | 266d? | 2018-06-06 A | 2019-06-12 | 75% | 66.5d? | 26222d | finish no earlier than 2019-06-12 | S6 | 2128h | 162.4h | FS_MCLOG | Chater-Lea, David, Motorola Solutions | david.chater-lea@motorolasolutions.com | Rel-16 | 80 | 41 |
| 137 | 94 | Study on location enhancements for mission critical services | 260d? | 2018-09-14 A | 2019-09-12 | 45% | 143d? | 26156d | finish no earlier than 2019-09-12 | S6 | 2080h |  | FS_enhMCLoc | Dom Lazara, Motorola Solutions | dom.lazara@motorolasolutions.com | Rel-16 | 81 | 41 |
| 138 | 95 | Enhanced Mission Critical Push-to-talk architecture phase 2 | 266d? | 2018-06-06 A | 2019-06-12 | 60% | 106.4d? | 26222d | finish no earlier than 2019-06-12 | S6 | 2128h | 80.8h | enh2MCPTT | Dom Lazara; Motorola Solutions | Dom.Lazara@motorolasolutions.com | Rel-16 | 80 | 41 |
| 139 | 96 | **Enhancements to Functional architecture and information flows for Mission Critical Data** | 397d? | 2018-06-06 A | 2019-12-12 | 43% | 225.02d? | 26091d |  | S6 | 6888h | 428.8h | eMCData2 | Shih, Jerry, AT&T | jerry.shih@att.com | Rel-16 | 80 | 41 |
| 140 | 96.1 | Stage 2 of eMCData2 | 268d? | 2018-06-06 A | 2019-06-14 | 75% | 67d? | 26220d | finish no earlier than 2019-06-14 | S6 | 2144h | 214.4h | eMCData2 | Shih, Jerry, AT&T | jerry.shih@att.com | Rel-16 | 80 | 41 |
| 141 | 96.2 | CT aspects of eMCData2 | 196d? | 2019-03-14 | 2019-12-12 |  |  | 26091d | finish no earlier than 2019-12-12 | ct | 1568h |  | eMCData2 | Val Oprescu (AT&T) | vo4887@att.com | Rel-16 |  |  |
| 142 | 97 | Study on Mission Critical services support over 5G System | 332d? | 2018-06-06 A | 2019-09-12 | 35% | 215.8d? | 26156d | finish no earlier than 2019-09-12 | S6 | 2656h | 81.2h | FS_MCOver5GS | Verweij, Kees, The Police of the Netherlands | kees.verweij@politie.nl | Rel-16 | 80 | 41 |
| 143 | 98 | MCData File Distribution support over xMB | 197d? | 2018-09-06 A | 2019-06-07 | 90% | 19.7d? | 26225d | finish no earlier than 2019-06-07 | S4 | 1576h |  | MC_XMB | Thiénot Cédric, Expway | cedric.thienot@expway.com | Rel-16 | 81 | 41 |
| 144 | 99 | Protocol enhancements for Mission Critical Services | 337d? | 2018-09-06 A | 2019-12-20 | 40% | 202.2d? | 26085d | finish no earlier than 2019-12-20 | C1 | 2696h |  | MCProtoc16 | AXELL, Jörgen | jorgen.axell@ericsson.com | Rel-16 | 81 | 41 |
| 145 | 100 | **MBMS APIs for Mission Critical Services** | 464d? | 2017-06-05 A | 2019-03-14 | 96% | 19.86d? | 26286d |  | S6 | 7488h | 5955.54h | MBMSAPI_MCS | Ling Zhang, TD Tech Ltd. | zhangling@td-tech.com | Rel-16 | 80 | 41 |
| 146 | 100.1 | Study on MBMS APIs for MC Services | 270d? | 2017-06-05 A | 2018-06-15 A | 100% |  |  | finish no earlier than 2018-06-15 | S6 | 2160h | 2160h | FS_MBMSAPI_MC | Ling Zhang, TD Tech Ltd | zhangling@td-tech.com | Rel-16 | 76 | 39 |
| 147 | 100.2 | Stage 2 of MBMS APIs for MC Services | 202d? | 2018-06-06 A | 2019-03-14 | 90% | 20.2d? | 26286d | finish no earlier than 2019-03-14 | S6 | 1616h | 242.4h | MBMSAPI_MCS | Ling Zhang, TD Tech Ltd. | zhangling@td-tech.com | Rel-16 | 80 | 41 |
| 148 | 101 | Enhanced Mission Critical System Migration and Interconnection | 266d? | 2018-06-06 A | 2019-06-12 | 50% | 133d? | 26222d | finish no earlier than 2019-06-12 | S6 | 2128h | 80.8h | eMCSMI | Chater-Lea, David; Motorola Solutions | david.chater-lea@motorolasolutions.com | Rel-16 | 80 | 41 |
| 149 | 102 | **Enhanced Mission Critical Communication Interworking with Land Mobile Radio Systems** | 268d? | 2018-06-06 A | 2019-06-14 | 40% | 160.8d? | 26220d |  |  | 2144h | 107.2h | eMCCI | Monnes, Peter, Harris Corporation | pmonnes@harris.com | Rel-16 | 80 | 41 |
| 150 | 102.1 | Enhanced Mission Critical Communication Interworking with Land Mobile Radio Systems | 268d? | 2018-06-06 A | 2019-06-14 | 40% | 160.8d? | 26220d | finish no earlier than 2019-06-14 | S6 | 2144h | 107.2h | eMCCI | Monnes, Peter, Harris Corporation | pmonnes at harris dot com | Rel-16 | 80 | 41 |
| 151 | 103 | Stage 3 for MC Communication Interworking with Land Mobile Radio Systems | 266d? | 2018-06-06 A | 2019-06-12 | 60% | 106.4d? | 26222d | finish no earlier than 2019-06-12 | C1 | 2128h | 165.6h | MCCI_CT | Monnes, Peter, Harris Corporation | pmonnes@harris.com | Rel-16 | 80 | 41 |
| 152 | 104 | Mission Critical system migration and interconnection | 135d | 2018-12-13 | 2019-06-19 |  |  | 26217d | start no earlier than 2018-12-13 | C1 | 1080h |  | MCSMI_CT | Dom Lazara, Motorola Solutions | dom.lazara@motorolasolutions.com | Rel-16 | 82 |  |
| 153 | 105 | Mission Critical Services Security Enhancements | 202d? | 2018-06-06 A | 2019-03-14 | 50% | 101d? | 26286d | finish no earlier than 2019-03-14 | S3 | 1616h | 646.4h | MCXSec | Woodward, Tim, Motorola Solutions, Inc |  | Rel-16 | 80 | 41 |

Notes:
- 128: Impacted TSs and TRs: 23.501; 23.502; 23.503
- 129: 14/3/19: 0%->50 / Impacted TSs and TRs: 23.501; 23.502; 23.503
- 131: Impacted TSs and TRs: 24.501; 24.502; 24.526
- 132: Impacted TSs and TRs: 29.512; 29.513; 29.514; 29.507; 29.122; 29.522
- 133: Impacted TSs and TRs: 23.003; 29.518; 29.502; 29.509; 29.244; 29.503; 29.571; 29.505
- 134: -
- 135: 19/4/18: 0%->5; 14/6/18: 5%->15; 15/6/18: WID:SP-180163->SP-180385; 15/6/18: FCD:12/18->03/19; 6/8/18: 23.778 added;; 10/9/18: 15%->25; 7/12/18: 25%->70; 14/12/18: WID:SP-180385->SP-181135; 14/3/19: FCD:03/19->06/19; 14/3/19: 70%->75 / Impacted TSs and TRs: new TR 23.xxx; 23.778
- 136: 6/8/18: 23.784 added;; 10/9/18: 0%->10; 7/12/18: 10%->50; 7/12/18: FCD:03/19->06/19; 14/12/18: WID:SP-180384->SP-181138; 14/3/19: 50%->75 / Impacted TSs and TRs: New; 23.784
- 137: 7/12/18: 0%->20; 14/3/19: 20%->45; 14/3/19: FCD:03/19->09/19
- 138: 10/9/18: 0%->5; 7/12/18: 5%->35; 14/3/19: 35%->60; 14/3/19: FCD:03/19->06/19 / Impacted TSs and TRs: 23.280; 23.379; 23.281; 23.282; 23.283
- 139: 10/9/18: 0%->10; 7/12/18: 10%->40
- 140: 10/9/18: 0%->10; 7/12/18: 10%->40; 14/3/19: 40%->75 / Impacted TSs and TRs: 23.280; 23.282
- 141: Impacted TSs and TRs: 24.282; 24.582; 24.483; 24.484; 24.zzz
- 142: 6/8/18: 23.783 added;; 10/9/18: 0%->5; 7/12/18: 5%->35; 7/12/18: FCD:03/19->09/19; 14/12/18: WID:SP-180383->SP-181136. 03/19: Rel corrected (was shown as Rel-17) / Impacted TSs and TRs: New; 23.783
- 143: 7/12/18: 0%->80; 7/3/19: 80%->90; 7/3/19: FCD:03/19->06/19 / Impacted TSs and TRs: 26.348
- 144: 7/12/18: 0%->20; 14/3/19: 20%->40 / Impacted TSs and TRs: 24.229; 24.281; 24.282; 24.379; 24.380; 24.481; 24.482; 24.483; 24.484; 24.581; 24.582; 24.980
- 145: Impacted TSs and TRs: New
- 146: 12/7/17: WID:SP-170596->SP-170598; 11/9/17: 0%->10; 15/12/17: 10%->20; 15/12/17: Changed Rel-15->Rel-16; 16/3/18: 20%->60; 23/3/18: WID:SP-170598->SP-180237; 23/3/18: FCD:03/18->06/18; 14/6/18: 60%->100 / Impacted TSs and TRs: new 23.792
- 147: 6/8/18: 23.479 added;; 10/9/18: 0%->15; 7/12/18: 15%->65; 14/3/19: 65%->90 / Impacted TSs and TRs: New; 23.479
- 148: 10/9/18: 0%->5; 7/12/18: 5%->10; 7/12/18: FCD:03/19->06/19; 14/3/19: 10%->50 / Impacted TSs and TRs: 23.280; 23.379; 23.281; 23.282; 23.283
- 150: 10/9/18: 0%->5; 2/10/18: WID:SP-180381->SP-180680; 7/12/18: 5%->15; 14/3/19: 15%->40 / Impacted TSs and TRs: 23.283
- 151: 10/9/18: 5%->15; 7/12/18: 15%->45; 10/12/18: FCD:12/18->06/19; 10/12/18: WID:CP-181187->CP-183247. 06/03/19: both name and acronym changed (was MCCI3); 14/3/19: 45%->60 / Impacted TSs and TRs: 24.379; 24.380; 24.282; 24.481; 24.483; 24.484; 24.482
- 152: Impacted TSs and TRs: 24.379; 24.380; 24.282; 24.481; 24.483; 24.484; 24.482
- 153: 10/9/18: 0%->40; 7/12/18: 40%->50 / Impacted TSs and TRs: 33.180

| ID | WBS | Task | Type | Duration | Start | Finish | Complete | Remaining | Total slack | Constraint | Resources | Work | Actual work | Acronym | PCG approved | WI rapporteur name | WI rapporteur e-mail | Release | TSG approved |
| --- | --- | --- | --- | --- | --- | --- | --- | --- | --- | --- | --- | --- | --- | --- | --- | --- | --- | --- | --- |
| 154 | 106 | **Enhancements of Public Warning System** |  | 845d? | 2016-09-19 A | 2019-12-13 | 48% | 440.29d? | 26090d |  |  | 12688h | 4451.65h | ePWS | 41 | Hyounhee Koo, SyncTechno Inc. | koo at synctechno dot com | Rel-16 | 80 |
| 155 | 106.1 | Study on enhancements of Public Warning System |  | 259d? | 2016-09-19 A | 2017-09-14 A | 100% |  |  | finish no earlier than 2017-09-14 | S1 | 2072h | 2072h | FS_ePWS | 37 | SyncTechno Inc., Hyounhee Koo | koo at synctechno dot com | Rel-16 | 73 |
| 156 | 106.2 | Stage 1 of ePWS |  | 261d? | 2017-12-15 A | 2018-12-14 A | 100% |  |  | finish no earlier than 2018-12-14 | S1 | 2088h | 2088h | ePWS | 41 | Hyounhee Koo, SyncTechno Inc. | koo at synctechno dot com | Rel-16 | 80 |
| 157 | 106.3 | **CT aspects of enhancements of Public Warning System** |  | 332d? | 2018-09-06 A | 2019-12-13 | 11% | 295.54d? | 26090d |  | ct | 8528h | 291.65h | ePWS | 41 | TaeHyeon Kim, SyncTechno Inc. | kim at synctechno dot com | Rel-16 | 81 |
| 158 | 106.3.1 | Study on stages 2 and 3 of enhancements of ePWS |  | 200d? | 2018-09-10 A | 2019-06-14 | 10% | 180d? | 26220d | finish no earlier than 2019-06-14 | C1 | 1600h |  | ePWS | 41 | TaeHyeon Kim, SyncTechno Inc. | kim at synctechno dot com | Rel-16 | 81 |
| 159 | 106.3.2 | CT1 aspects of ePWS |  | 202d? | 2018-09-06 A | 2019-06-14 | 30% | 141.4d? | 26220d | finish no earlier than 2019-06-14 | C1 | 1616h |  | ePWS | 41 | TaeHyeon Kim, SyncTechno Inc. | kim at synctechno dot com | Rel-16 | 81 |
| 160 | 106.3.3 | CT4 aspects of ePWS (Possible impacts) |  | 332d? | 2018-09-06 | 2019-12-13 |  |  | 26090d | finish no earlier than 2019-12-13 | C4 | 2656h |  | ePWS | 41 | TaeHyeon Kim, SyncTechno Inc. | kim at synctechno dot com | Rel-16 | 81 |
| 161 | 107 | **Mobile Communication System for Railways 2** |  | 530d? | 2017-06-05 A | 2019-06-14 | 95% | 27.87d? | 0d |  |  | 10040h | 9512h | MONASTERY2 | 39 | Merkel, Juergen, Nokia | juergen.merkel@nokia.com | Rel-16 | 76 |
| 162 | 107.1 | Study on MONASTERY2 |  | 530d? | 2017-06-05 A | 2019-06-14 A | 100% |  |  | finish no earlier than 2019-06-14 | S1 | 4240h | 4240h | FS_FRMCS2 | 39 | Merkel, Juergen, Nokia | juergen.merkel@nokia.com | Rel-16 | 76 |
| 163 | 107.2 | Study on application architecture for the Future Railway Mobile Communication System (FRMCS) Phase 2 |  | 259d? | 2018-03-15 A | 2019-03-12 A | 100% |  |  | finish no earlier than 2019-03-12 | S6 | 2072h | 2072h | FS_FRMCS2_SA6 | 40 | Oettl, Martin, Nokia | martin(dot)oettl(at)nokia(dot)com | Rel-16 | 79 |
| 164 | 107.3 | Stage 1 of MONASTERY2 |  | 400d? | 2017-06-05 A | 2018-12-14 A | 100% |  |  | finish no earlier than 2018-12-14 | S1 | 3200h | 3200h | MONASTERY2 | 39 | Merkel, Juergen, Nokia | juergen.merkel@nokia.com | Rel-16 | 76 |
| 165 | 107.4 | Application Architecture for MONASTERY2 | manual | 66d | 2019-03-14 | 2019-06-13 |  |  |  |  | S6 | 528h |  | MONASTERY2 |  | Oettl, Martin, Nokia | martin(dot)oettl(at)nokia(dot)com | Rel-16 |  |
| 166 | 108 | **Maritime Communication Services over 3GPP System** |  | 584d? | 2016-09-19 A | 2018-12-13 A | 100% |  |  |  | S1 | 5950h | 5950h | MARCOM | 41 | Hyounhee Koo, SyncTechno Inc | koo at synctechno dot com | Rel-16 | 80 |
| 167 | 108.1 | Study on Maritime Communication Services over 3GPP system |  | 455d? | 2016-09-19 A | 2018-06-15 A | 100% |  |  | finish no earlier than 2018-06-15 | S1 | 3640h | 3640h | FS_MARCOM | 37 | SyncTechno Inc., Hyounhee Koo | koo at synctechno dot com | Rel-16 | 73 |
| 168 | 108.2 | Stage 1 of MARCOM |  | 137d? | 2018-06-06 A | 2018-12-13 A | 100% |  |  | finish no earlier than 2018-12-13 | S1 | 1096h | 1096h | MARCOM | 41 | Hyounhee Koo, SyncTechno Inc | koo at synctechno dot com | Rel-16 | 80 |
| 169 | 109 | Streaming and TV |  | 655d? | 2016-12-01 A | 2019-06-05 | 68% | 209.6d? | 26227d |  |  |  |  |  |  |  |  | Rel-16 |  |
| 170 | 110 | **Enhancement of LTE for Efficient delivery of Streaming Service** |  | 467d? | 2016-12-01 A | 2018-09-14 A | 100% |  |  |  | S1 | 7176h | 7176h | eLSTR | 41 | Xia, Xu, China Telecom | xiaxu.bri@chinatelecom.cn | Rel-16 | 80 |
| 171 | 110.1 | Study on eLSTR |  | 336d? | 2016-12-01 A | 2018-03-15 A | 100% |  |  | finish no earlier than 2018-03-15 | S1 | 2688h | 2688h | FS_eLESTR | 38 | China Telecommunications, XIA Xu | xiaxu@ctbri.com.cn | Rel-16 | 74 |
| 172 | 110.2 | Stage 1 of eLSTR |  | 94d? | 2018-05-08 A | 2018-09-14 A | 100% |  |  | finish no earlier than 2018-09-14 | S1 | 752h | 752h | eLSTR | 41 | Xia, Xu, China Telecom | xiaxu.bri@chinatelecom.cn | Rel-16 | 80 |
| 173 | 111 | Enhancements to Framework for Live Uplink Streaming |  | 338d? | 2018-06-06 A | 2019-09-20 | 45% | 185.9d? | 26150d | finish no earlier than 2019-09-20 | S4 | 2704h | 323.2h | E-FLUS | 41 | Lo, Charles, Qualcomm Incorporated | clo@qti.qualcomm.com | Rel-16 | 80 |
| 174 | 112 | Coverage and Handoff Enhancements for Multimedia |  | 197d? | 2018-09-06 A | 2019-06-07 | 80% | 39.4d? | 26225d | finish no earlier than 2019-06-07 | S4 | 1576h |  | CHEM | 41 | Nikolai Leung | nleung@qti.qualcomm.com | Rel-16 | 81 |
| 175 | 113 | Study on QoE metrics for VR |  | 531d? | 2017-09-08 A | 2019-09-20 | 55% | 238.95d? | 26150d | finish no earlier than 2019-09-20 | S4 | 4248h | 662h | FS_QoE_VR | 39 | Ericsson (Gunnar Heikkilä | gunnar.heikkila@ericsson.com | Rel-16 | 77 |
| 176 | 114 | Study on 5G enhanced Mobile Broadband Media Distribution |  | 335d? | 2017-06-05 A | 2018-09-14 | 75% | 83.75d? | 26415d | finish no earlier than 2018-09-14 | S4 | 2680h | 2010h | FS_5GMedia_Distribution | 39 | Bouazizi, Imed, Samsung Electronics Co., Ltd., | i (dot) Bouazizi (at) Samsung (dot) com | Rel-16 | 76 |
| 177 | 115 | Media streaming architecture | manual | 135d | 2018-12-06 | 2019-06-12 |  |  |  |  | S4 | 1080h |  | 5GMSA |  | Frédéric GABIN | Frederic.gabin@ericsson.com | Rel-16 | 82 |

Notes:
- 154: 16/3/18: 0%->100
- 155: 22.xxx; 1/12/16: 0%->5; 2/3/17: 5%->45; 7/6/17: 45%->75; 30/6/17: 22.869 added;; 25/8/17: 75%->95; 15/12/17: 95%->100 / Impacted TSs and TRs: 22.869
- 156: 16/3/18: 0%->100
- 158: 7/12/18: 0%->10 / Impacted TSs and TRs: New
- 159: 14/3/19: 0%->30 / Impacted TSs and TRs: 23.041
- 160: Impacted TSs and TRs: 29.168
- 161: 15/12/17: 10%->35 / Impacted TSs and TRs: New 22.289; 22.280; 22.281; 22.282; 22.179
- 162: 15/12/17: 35%->50; 16/3/18: 50%->80; 7/6/18: 80%->85; 10/9/18: FCD:06/18->06/19; 4/12/18: 85%->100 / Impacted TSs and TRs: New 22.889
- 163: 19/4/18: 0%->5; 14/6/18: 5%->15; 6/8/18: 23.796 added;; 10/9/18: 15%->20; 7/12/18: 20%->65; 7/12/18: FCD:12/18->03/19; 14/3/19: 65%->100 / Impacted TSs and TRs: TR 23.cde; 23.796
- 164: 16/3/18: 35%->55; 7/6/18: 55%->70; 7/6/18: FCD:06/18->12/18; 10/9/18: 70%->75; 4/12/18: 75%->100 / Impacted TSs and TRs: New 22.289; 22.280; 22.281; 22.282; 22.179
- 165: Impacted TSs and TRs: 23.280; 23.379; 23.281; 23.282
- 166: Impacted TSs and TRs: 22.179; 22.280; 22.281; 22.282; 22.261; 22.346; 22.468
- 167: 22.xxx; 1/12/16: 0%->10; 2/3/17: 10%->15; 2/3/17: WID:SP-160556->SP-170166; 10/3/17: FCD:06/17->06/20; 21/3/17: 22.819 added;; 8/6/17: WID:SP-170166->SP-170453; 25/8/17: 15%->35; 15/12/17: 35%->55; 16/3/18: 55%->75; 7/6/18: 75%->95; 10/9/18: 95%->100 / Impacted TSs and TRs: 22.819
- 168: 10/9/18: 0%->70; 4/12/18: 70%->95; 14/3/19: 95%->100 / Impacted TSs and TRs: 22.119; 22.179; 22.280; 22.281; 22.282; 22.261; 22.346; 22.468
- 169: -
- 170: Impacted TSs and TRs: 22.278; 22.115
- 171: 2/3/17: 0%->20; 7/6/17: 20%->50; 11/9/17: 50%->70; 15/12/17: 70%->75; 15/12/17: FCD:09/17->03/18; 16/3/18: 75%->100 / Impacted TSs and TRs: 22.833
- 172: 15/6/18: FCD:06/18->09/18; 10/9/18: 90%->100 / Impacted TSs and TRs: 22.278; 22.115
- 173: 10/9/18: 0%->20; 7/12/18: 20%->40; 7/3/19: 40%->45; 7/3/19: FCD:03/19->09/19 / Impacted TSs and TRs: 26.238; 26.939
- 174: 7/12/18: 0%->70; 7/3/19: 70%->80; 7/3/19: FCD:03/19->06/19 / Impacted TSs and TRs: 26.114
- 175: 15/12/17: 26.929 added;; 15/12/17: 26.119 added;; 15/12/17: FCD:06/18->09/18; 15/12/17: 0%->10; 16/3/18: 10%->15; 7/6/18: 15%->20; 7/6/18: FCD:09/18->12/18. 14/06/18: Moved from Rel-15; 10/9/18: 20%->25; 12/3/19: 25%->55; 12/3/19: FCD:12/18->09/19 / Impacted TSs and TRs: New; 26.929; 26.119
- 176: 11/9/17: 0%->10; 15/12/17: FCD:03/18->06/20; 15/12/17: 10%->25; 16/3/18: 25%->60; 7/6/18: 60%->70; 7/6/18: FCD:06/18->09/18. 14/06/18: Moved from Rel-15; 10/9/18: 70%->75 / Impacted TSs and TRs: 26.8xx
- 177: Impacted TSs and TRs: 26.501; 26.233

| ID | WBS | Task | Type | Duration | Start | Finish | Complete | Remaining | Total slack | Constraint | Resources | Work | Actual work | Acronym | PCG approved | WI rapporteur name | WI rapporteur e-mail | Release | TSG approved |
| --- | --- | --- | --- | --- | --- | --- | --- | --- | --- | --- | --- | --- | --- | --- | --- | --- | --- | --- | --- |
| 178 | 116 | **Media Handling Extensions for 5G Conversational Services** |  | 595d? | 2017-06-05 A | 2019-09-13 | 78% | 131.95d? | 26155d |  | S4 | 9576h | 6384.42h | 5G_MEDIA_MTSI_ext | 41 | Oyman, Ozgur, Company: Intel | ozgur.oyman@intel.com | Rel-16 | 81 |
| 179 | 116.1 | Study on Media Handling Aspects of Conversational Services in 5G Systems |  | 335d? | 2017-06-05 A | 2018-09-15 A | 100% |  |  | finish no earlier than 2018-09-15 | S4 | 2680h | 2680h | FS_5G_MEDIA_MTSI | 39 | Oyman, Ozgur, Company: Intel | ozgur.oyman@intel.com | Rel-16 | 76 |
| 180 | 116.2 | Media Handling Extensions for 5G Conversational Services |  | 267d? | 2018-09-06 A | 2019-09-13 | 50% | 133.5d? | 26155d | finish no earlier than 2019-09-13 | S4 | 2136h |  | 5G_MEDIA_MTSI_ext | 41 | Oyman, Ozgur, Company: Intel | ozgur.oyman@intel.com | Rel-16 | 81 |
| 181 | 117 | Study on EVS Float Conformance Non Bit-Exact |  | 266d? | 2017-09-08 A | 2018-09-14 A | 100% |  |  | finish no earlier than 2018-09-14 | S4 | 2128h | 2128h | FS_EVS_FCNBE | 39 | Fabrice Plante, Intel | fabrice.m.plante@intel.com | Rel-16 | 77 |
| 182 | 118 | EVS Floating-point Conformance for Non Bit-Exact |  | 332d? | 2018-06-06 A | 2019-09-12 | 25% | 249d? | 26156d | finish no earlier than 2019-09-12 | S4 | 2656h |  | EVS_FCNBE |  | Fabrice, Plante, Intel | fabrice.m.plante@intel.om | Rel-16 | 82 |
| 183 | 119 | Addition of HLG HDR to TV Video Profiles |  | 73d? | 2018-06-06 A | 2018-09-14 A | 100% |  |  | finish no earlier than 2018-09-14 | S4 | 584h | 584h | HLG_HDR | 41 | Paul Szucs, Sony Europe Limited | paul.szucs@sony.com | Rel-16 | 80 |
| 184 | 120 | User Identities, Authentication, multi-device | milestone | 0d? | 2017-12-15 A | 2017-12-15 A | 100% |  |  | finish no earlier than 2017-12-15 |  |  |  |  |  |  |  | Rel-16 |  |
| 185 | 121 | **User Identities and Authentication** |  | 196d? | 2017-12-15 A | 2018-09-14 A | 100% |  |  |  | S1 | 3192h | 3192h | UIA | 41 | Bischinger, Kurt; Deutsche Telekom | kurt.bischinger@t-mobile.at | Rel-16 | 80 |
| 186 | 121.1 | Study on a Layer for User Centric Identifiers and Authentication |  | 130d? | 2017-12-15 A | 2018-06-14 A | 100% |  |  | finish no earlier than 2018-06-14 | S1 | 1040h | 1040h | FS_LUCIA | 40 | Bischinger, Kurt; Deutsche Telekom | kurt.bischinger@t-mobile.at | Rel-16 | 78 |
| 187 | 121.2 | Stage 1 of User Identities and Authentication |  | 73d? | 2018-06-06 A | 2018-09-14 A | 100% |  |  | finish no earlier than 2018-09-14 | S1 | 584h | 584h | UIA | 41 | Bischinger, Kurt; Deutsche Telekom | kurt.bischinger@t-mobile.at | Rel-16 | 80 |
| 188 | 122 | **Multi-device and multi-identity** |  | 268d? | 2018-06-06 A | 2019-06-14 | 24% | 204.29d? | 26220d |  | S1 | 7576h | 1198.62h | MuD | 41 | Peter Bleckert, Ericsson | Peter.Bleckert@ericsson.com | Rel-16 | 80 |
| 189 | 122.1 | Stage 1 of Multi-device and multi-identity |  | 73d? | 2018-06-06 A | 2018-09-14 A | 100% |  |  | finish no earlier than 2018-09-14 | S1 | 584h | 584h | MuD | 41 | Peter Bleckert, Ericsson | Peter.Bleckert@ericsson.com | Rel-16 | 80 |
| 190 | 122.2 | **CT aspects of Multi-device and multi-identity** |  | 202d? | 2018-09-06 A | 2019-06-14 | 10% | 181.8d? | 26220d |  | ct | 4848h | 161.6h | MuD | 41 | Axell, Jörgen, Ericsson | Jorgen.Axell@ericsson.com | Rel-16 | 81 |
| 191 | 122.2.1 | CT1 aspects of Multi-device and multi-identity |  | 202d? | 2018-09-06 A | 2019-06-14 | 15% | 171.7d? | 26220d | finish no earlier than 2019-06-14 | C1 | 1616h |  | MuD | 41 | Axell, Jörgen, Ericsson | Jorgen.Axell@ericsson.com | Rel-16 | 81 |
| 192 | 122.2.2 | CT3 aspects of Multi-device and multi-identity |  | 202d? | 2018-09-06 A | 2019-06-14 | 5% | 191.9d? | 26220d | finish no earlier than 2019-06-14 | C3 | 1616h |  | MuD | 41 | Axell, Jörgen, Ericsson | Jorgen.Axell@ericsson.com | Rel-16 | 81 |
| 193 | 123 | Slicing | milestone | 0d? | 2017-09-08 A | 2017-09-08 A | 100% |  |  | finish no earlier than 2017-09-08 |  |  |  |  |  |  |  | Rel-16 |  |
| 194 | 124 | Study on Enhancement of Network Slicing |  | 197d? | 2018-03-15 A | 2018-12-14 A | 100% |  |  | start no earlier than 2018-03-15 | S2 | 1576h | 1576h | FS_eNS | 40 | ZTE, Tricci So | tso at ztetx dot com | Rel-16 | 79 |
| 195 | 125 | **Enhancement of Network Slicing** |  | 256d | 2018-12-13 A | 2019-12-05 | 11% | 227.15d | 26096d |  |  | 7360h |  | eNS |  | ZTE, Tricci So | tso at ztetx dot com | Rel-16 |  |
| 196 | 125.1 | Stage 2 of eNS |  | 136d | 2018-12-13 A | 2019-06-20 | 60% | 54.4d | 26216d | start no earlier than 2018-12-13 | S2 | 1088h |  | eNS |  | ZTE, Tricci So | tso at ztetx dot com | Rel-16 | 82 |
| 197 | 125.2 | **CT aspects of eNS** |  | 196d | 2019-03-07 | 2019-12-05 |  |  | 26096d |  | ct | 6272h |  | eNS |  | Fei Lu, ZTE | lu.fei1@zte.com.cn | Rel-16 |  |
| 198 | 125.2.1 | CT1 aspects of eNS |  | 196d | 2019-03-07 | 2019-12-05 |  |  | 26096d |  | C1 | 1568h |  | eNS |  | Fei Lu, ZTE | lu.fei1@zte.com.cn | Rel-16 |  |
| 199 | 125.2.2 | CT3 aspects of eNS |  | 196d | 2019-03-07 | 2019-12-05 |  |  | 26096d |  | C3 | 1568h |  | eNS |  | Fei Lu, ZTE | lu.fei1@zte.com.cn | Rel-16 |  |
| 200 | 125.2.3 | CT4 aspects of eNS |  | 196d | 2019-03-07 | 2019-12-05 |  |  | 26096d |  | C4 | 1568h |  | eNS |  | Fei Lu, ZTE | lu.fei1@zte.com.cn | Rel-16 |  |
| 201 | 126 | **Business Role Models for Network Slicing** |  | 330d? | 2017-09-08 A | 2018-12-13 A | 100% |  |  |  | S1 | 5336h | 5336h | BRMNS | 41 | Covell, Betsy, Nokia | betsy.covell@nokia.com | Rel-16 | 81 |
| 202 | 126.1 | Study on Business Role Models for Network Slicing |  | 266d? | 2017-09-08 A | 2018-09-14 A | 100% |  |  | start no earlier than 2017-09-08 | S1 | 2128h | 2128h | FS_BMNS | 39 | Covell, Betsy, Nokia | betsy.covell@nokia.com | Rel-16 | 77 |
| 203 | 126.2 | Business Role Models for Network Slicing |  | 71d? | 2018-09-06 A | 2018-12-13 A | 100% |  |  | finish no earlier than 2018-12-13 | S1 | 568h | 568h | BRMNS | 41 | Covell, Betsy, Nokia | betsy.covell@nokia.com | Rel-16 | 81 |
| 204 | 127 | Study on Security aspects of Enhancement of Network Slicing |  | 137d? | 2018-09-06 A | 2019-03-15 | 15% | 116.45d? | 26285d | finish no earlier than 2019-03-15 | S3 | 1096h |  | FS_eNS_SEC | 41 |  | Suresh.p.nair@nokia.com | Rel-16 | 81 |
| 205 | 128 | Study on tenancy concept in 5G networks and network slicing management |  | 202d? | 2018-09-06 A | 2019-06-14 | 26% | 149.48d? | 26220d | finish no earlier than 2019-06-14 | S5 | 1616h |  | FS_TENANCYC | 41 | ZHU, Lei (Huawei | Lei.zhu@huawei.com | Rel-16 | 81 |
| 206 | 129 | Enhancement of performance assurance for 5G networks including network slicing |  | 202d? | 2018-09-06 A | 2019-06-14 | 60% | 80.8d? | 26220d | finish no earlier than 2019-06-14 | S5 | 1616h |  | 5G_SLICE_ePA | 41 | Xiaowei Sun (China Mobile) |  | Rel-16 | 81 |
| 207 | 130 | Study on Charging Aspects of Network Slicing |  | 196d | 2018-12-13 A | 2019-09-12 | 30% | 137.2d | 26156d | finish no earlier than 2019-09-12 | S5 | 1568h |  | FS_NETSLICE_CH |  | Chen Shan, Huawei | chenshan@huawei.com | Rel-16 | 82 |
| 208 | 131 | All other Release 16 Features | milestone | 0d? | 2016-06-09 A | 2016-06-09 A | 100% |  |  | finish no earlier than 2016-06-09 |  |  |  |  |  |  |  | Rel-16 |  |

Notes:
- 178: Impacted TSs and TRs: 26.114
- 179: 11/9/17: 0%->5; 15/12/17: 5%->35; 16/3/18: 35%->55; 16/3/18: FCD:03/18->09/18; 7/6/18: 55%->80. 14/06/18: Moved from Rel-15; 10/9/18: 80%->100 / Impacted TSs and TRs: 26.919
- 180: 7/12/18: 0%->35; 7/3/19: 35%->50 / Impacted TSs and TRs: 26.114
- 181: 15/12/17: 26.843 added;; 15/12/17: 0%->50; 16/3/18: 50%->60; 16/3/18: FCD:03/18->06/18; 7/6/18: 60%->70; 7/6/18: FCD:06/18->09/18. 14/06/18: Moved from Rel-15; 10/9/18: 70%->100 / Impacted TSs and TRs: New; 26.843
- 182: ; 7/3/19: 0%->25; 7/3/19: 0%->25; 7/3/19: 0%->25. CANNOT CHANGE STARTING DATE… Real one: Thu 06/12/18 / Impacted TSs and TRs: 26.444
- 183: 10/9/18: 0%->100 / Impacted TSs and TRs: 26.116; 26.346; 26.234
- 184: -
- 185: Impacted TSs and TRs: 22.101; 22.115
- 186: 16/3/18: 0%->60; 7/6/18: 60%->90; 10/9/18: 90%->100 / Impacted TSs and TRs: 22.904
- 187: 10/9/18: 0%->100 / Impacted TSs and TRs: 22.101; 22.115
- 189: 10/9/18: 85%->90; 4/12/18: 90%->100 / Impacted TSs and TRs: 22.173
- 191: 7/12/18: 0%->10; 14/3/19: 10%->15 / Impacted TSs and TRs: 24.173; 24.229; 24.167
- 192: 7/12/18: 0%->5 / Impacted TSs and TRs: 29.165
- 193: -
- 194: 7/6/18: 0%->10; 15/6/18: WID:SP-180121->SP-180503; 6/8/18: 23.740 added;; 10/9/18: 10%->50; 7/12/18: 50%->85; 7/12/18: 85%->; 14/3/19: 85%->100 / Impacted TSs and TRs: new; 23.740
- 196: 14/3/19: 0%->60
- 198: Impacted TSs and TRs: 24.501
- 199: Impacted TSs and TRs: 29.061; 29.561
- 200: Impacted TSs and TRs: 29.502; 29.503; 29.505; 29.509; 29.518
- 201: Impacted TSs and TRs: 22.261
- 202: 15/12/17: 22.830 added;; 15/12/17: 0%->10; 15/3/18: WID:SP-170705->SP-180169; 16/3/18: 10%->50; 7/6/18: 50%->75; 10/9/18: 75%->95; 4/12/18: 95%->100 / Impacted TSs and TRs: New; 22.830
- 203: 10/9/18: 0%->95; 4/12/18: 95%->100 / Impacted TSs and TRs: 22.261
- 204: 7/12/18: 0%->15 / Impacted TSs and TRs: New
- 205: 7/12/18: 0%->20; 14/3/19: 20%->26 / Impacted TSs and TRs: New
- 206: 7/12/18: 0%->30; 17/1/19: WID:SP-180843->SP-180906; 14/3/19: 30%->60 / Impacted TSs and TRs: 28.550; 28.532; 28.552; 28.554; 32.425; 32.426; 32.450; 32.451; 32.455;
- 207: 14/3/19: 0%->30; 14/3/19: FCD:06/19->09/19
- 208: -

| ID | WBS | Task | Type | Duration | Start | Finish | Complete | Remaining | Total slack | Constraint | Resources | Work | Actual work | Acronym | Release | TSG approved | PCG approved | WI rapporteur name | WI rapporteur e-mail |
| --- | --- | --- | --- | --- | --- | --- | --- | --- | --- | --- | --- | --- | --- | --- | --- | --- | --- | --- | --- |
| 209 | 132 | **Enhancing Topology of SMF and UPF in 5G Networks** |  | 586d? | 2017-09-08 A | 2019-12-06 | 46% | 318.45d? | 26095d |  |  | 8448h | 2648h | ETSUN | Rel-16 | 82 |  |  |  |
| 210 | 132.1 | Study on ETSUN |  | 331d? | 2017-09-08 A | 2018-12-14 A | 100% |  |  | finish no earlier than 2018-12-15 | S2 | 2648h | 2648h | FS_ETSUN | Rel-16 | 77 | 39 | Laurent Thiebaut (Nokia) | Laurent.thiebaut@nokia.com |
| 211 | 132.2 | Stage 2 of ETSUN |  | 137d | 2018-12-07 A | 2019-06-17 | 45% | 75.35d | 26219d | start no earlier than 2018-12-07 | S2 | 1096h |  | ETSUN | Rel-16 | 82 |  |  |  |
| 212 | 132.3 | **CT aspects of ETSUN** |  | 196d | 2019-03-08 | 2019-12-06 |  |  | 26095d |  | ct | 4704h |  | ETSUN | Rel-16 |  |  | Landais, Bruno, Nokia | bruno.landais@nokia.com |
| 213 | 132.3.1 | CT3 aspects of ETSUN |  | 196d | 2019-03-08 | 2019-12-06 |  |  | 26095d | start no earlier than 2019-03-08 | C3 | 1568h |  | ETSUN | Rel-16 |  |  | Landais, Bruno, Nokia | bruno.landais@nokia.com |
| 214 | 132.3.2 | CT4 aspects of ETSUN |  | 196d | 2019-03-08 | 2019-12-06 |  |  | 26095d | start no earlier than 2019-03-08 | C4 | 1568h |  | ETSUN | Rel-16 |  |  | Landais, Bruno, Nokia | bruno.landais@nokia.com |
| 215 | 133 | **Access Traffic Steering, Switch and Splitting support in the 5G system architecture** |  | 656d? | 2017-06-05 A | 2019-12-09 | 41% | 386.83d? | 26094d |  |  | 10560h | 3200h | ATSSS | Rel-16 | 82 |  | So, Tricci, ZTE | tso@ztetx.com |
| 216 | 133.1 | Study on ATSSS |  | 400d? | 2017-06-05 A | 2018-12-14 A | 100% |  |  | finish no earlier than 2018-12-15 | S2 | 3200h | 3200h | FS_ATSSS | Rel-16 | 76 | 39 | So, Tricci, ZTE | tso@ztetx.com |
| 217 | 133.2 | Stage 2 of ATSSS |  | 136d | 2018-12-14 A | 2019-06-21 | 45% | 74.8d | 26215d | start no earlier than 2018-12-14 | S2 | 1088h |  | ATSSS | Rel-16 | 82 |  | So, Tricci, ZTE | tso@ztetx.com |
| 218 | 133.3 | **CT aspects of ATSSS** |  | 196d | 2019-03-11 | 2019-12-09 |  |  | 26094d |  | ct | 6272h |  | ATSSS | Rel-16 |  |  | ZHOU, Xingyue (Joy), ZTE | zhou.xingyue@zte.com.cn |
| 219 | 133.3.1 | CT1 aspects of ATSSS |  | 196d | 2019-03-11 | 2019-12-09 |  |  | 26094d | start no earlier than 2019-03-11 | C1 | 1568h |  | ATSSS | Rel-16 |  |  | ZHOU, Xingyue (Joy), ZTE | zhou.xingyue@zte.com.cn |
| 220 | 133.3.2 | CT3 aspects of ATSSS |  | 196d | 2019-03-11 | 2019-12-09 |  |  | 26094d | start no earlier than 2019-03-11 | C3 | 1568h |  | ATSSS | Rel-16 |  |  | ZHOU, Xingyue (Joy), ZTE | zhou.xingyue@zte.com.cn |
| 221 | 133.3.3 | CT4 aspects of ATSSS |  | 196d | 2019-03-11 | 2019-12-09 |  |  | 26094d | start no earlier than 2019-03-11 | C4 | 1568h |  | ATSSS | Rel-16 |  |  | ZHOU, Xingyue (Joy), ZTE | zhou.xingyue@zte.com.cn |
| 222 | 134 | **Single radio voice continuity from 5GS to 3G** |  | 325d? | 2018-03-15 A | 2019-06-12 | 61% | 126.88d? | 26222d |  |  | 2664h | 1624h | 5G_SRVCC | Rel-16 | 81 | 41 | Chi Ren, China Unicom | renchi1@chinaunicom.cn |
| 223 | 134.1 | Study for single radio voice continuity from 5GS to 3G |  | 67d? | 2018-03-15 A | 2018-06-15 A | 100% |  |  | finish no earlier than 2018-06-15 | S2 | 536h | 536h | FS_5G-SRVCC | Rel-16 | 79 | 40 | Chi Ren, China Unicom | renchi1@chinaunicom.cn |
| 224 | 134.2 | Single radio voice continuity from 5GS to 3G |  | 136d? | 2018-09-06 A | 2019-03-14 A | 100% |  |  | finish no earlier than 2019-03-14 | S2 | 1088h | 1088h | 5G_SRVCC | Rel-16 | 81 | 41 | Chi Ren, China Unicom | renchi1@chinaunicom.cn |
| 225 | 134.3 | Security aspects of single radio voice continuity from 5GS to UTRAN |  | 130d | 2018-12-13 | 2019-06-12 |  |  | 26222d | start no earlier than 2018-12-13 | S3 | 1040h |  | 5GS_UTRAN_SEC | Rel-16 | 82 |  | Feng Gao, China Unicom | gaofeng149@chinaunicom.cn |
| 226 | 135 | **Remote Identification of Unmanned Aerial Systems** |  | 197d? | 2018-03-15 A | 2018-12-14 A | 100% |  |  |  |  | 1632h | 1632h | ID_UAS | Rel-16 | 81 | 41 | Eddy HALL, Qualcomm incorporated | edhall@qti.qualcomm.com |
| 227 | 135.1 | Study on Remote Identification of Unmanned Aerial Systems |  | 132d? | 2018-03-15 A | 2018-09-14 A | 100% |  |  | finish no earlier than 2018-09-14 | S1 | 1056h | 1056h | FS_ID_UAS | Rel-16 | 79 | 40 | Eddy Hall; Qualcomm Incorporated | edhall@qti.qualcomm.com |
| 228 | 135.2 | Stage 1 of Remote Identification of Unmanned Aerial Systems |  | 72d? | 2018-09-06 A | 2018-12-14 A | 100% |  |  | finish no earlier than 2018-12-14 | S1 | 576h | 576h | ID_UAS | Rel-16 | 81 | 41 | Eddy HALL, Qualcomm incorporated | edhall@qti.qualcomm.com |
| 229 | 136 | **Enhancements to the Service-Based 5G System Architecture** |  | 456d? | 2018-03-15 A | 2019-12-12 | 37% | 289.32d? | 26091d |  | S2 | 11016h | 1576h | 5G_eSBA | Rel-16 | 82 |  |  |  |
| 230 | 136.1 | Study on Enhancements to the Service-Based 5G System Architecture |  | 197d? | 2018-03-15 A | 2018-12-14 A | 100% |  |  | finish no earlier than 2018-12-14 | S2 | 1576h | 1576h | FS_eSBA | Rel-16 | 79 | 40 | Tao Sun (China Mobile) | suntao@chinamobile.com |
| 231 | 136.2 | Stage 2 of 5G_eSBA |  | 136d | 2018-12-13 A | 2019-06-20 | 50% | 68d | 26216d | start no earlier than 2018-12-13 | S2 | 1088h |  | 5G_eSBA | Rel-16 | 82 |  | Tao Sun (China Mobile) | suntao@chinamobile.com |
| 232 | 136.3 | **CT aspects of 5G_eSBA** |  | 196d | 2019-03-14 | 2019-12-12 |  |  | 26091d |  | ct | 4704h |  | 5G_eSBA | Rel-16 |  |  | Song Yue (China Mobile) | songyue at chinamobile dot com |
| 233 | 136.3.1 | CT3 aspects of 5G_eSBA |  | 196d | 2019-03-14 | 2019-12-12 |  |  | 26091d | start no earlier than 2019-03-14 | C3 | 1568h |  | 5G_eSBA | Rel-16 |  |  | Song Yue (China Mobile) | songyue at chinamobile dot com |
| 234 | 136.3.2 | CT4 aspects of 5G_eSBA |  | 196d | 2019-03-14 | 2019-12-12 |  |  | 26091d | start no earlier than 2019-03-14 | C4 | 1568h |  | 5G_eSBA | Rel-16 |  |  | Song Yue (China Mobile) | songyue at chinamobile dot com |
| 235 | 137 | Study on Enhanced IMS to 5GC Integration |  | 391d? | 2017-12-15 A | 2019-06-14 | 70% | 117.3d? | 26220d | finish no earlier than 2019-06-14 | S2 | 3128h | 1251.2h | FS_eIMS5G | Rel-16 | 78 | 40 | Joul, Chris, T-Mobile USA | chris <dot> joul <at> t-mobile <dot> com |
| 236 | 138 | SBA aspects of enhanced IMS to 5GC integration | manual | 65.88d | 2019-03-14 | 2019-06-13 |  |  |  |  | S2 | 527h |  | eIMS5G_SBA | Rel-16 |  |  | T-Mobile USA, Christopher Joul |  |

Notes:
- 210: 15/12/17: 23.726 added;; 16/3/18: 0%->25; 7/6/18: 25%->40; 10/9/18: 40%->65; 10/9/18: FCD:09/18->12/18; 2/10/18: WID:SP-170743->SP-180731; 2/10/18: FCD:12/18->12/18; 7/12/18: 65%->100 / Impacted TSs and TRs: 23.726
- 211: 14/3/19: 0%->45
- 213: Impacted TSs and TRs: 29.508; 29.561
- 214: Impacted TSs and TRs: 29.244; 29.502; 29.510; 29.518; 29.281
- 215: Impacted TSs and TRs: 23.501; 23.502; 23.503
- 216: 11/9/17: 0%->100; 14/9/17: 100%->10; 15/12/17: Changed Rel-15->Rel-16; 16/3/18: 10%->20; 7/6/18: 20%->40; 10/9/18: 40%->70; 10/9/18: FCD:09/18->12/18; 2/10/18: WID:SP-170411->SP-180732; 2/10/18: FCD:12/18->12/18; 7/12/18: 70%->100 / Impacted TSs and TRs: new 23.793
- 217: 14/3/19: 0%->45 / Impacted TSs and TRs: 23.501; 23.502; 23.503
- 219: Impacted TSs and TRs: 24.501; 24.526; 24.502
- 220: Impacted TSs and TRs: 29.512; 29.513
- 221: Impacted TSs and TRs: 29.244; 29.502; 29.503; 29.505; 29.518; 29.510; 23.008
- 222: Impacted TSs and TRs: 23.216; 23.501; 23.502
- 223: 7/6/18: 0%->80; 6/8/18: 23.756 added;; 10/9/18: 80%->100 / Impacted TSs and TRs: 23.756
- 224: 14/3/19: 0%->100 / Impacted TSs and TRs: 23.216; 23.501; 23.502
- 225: Impacted TSs and TRs: 33.501
- 227: 7/6/18: 0%->60; 10/9/18: 60%->100 / Impacted TSs and TRs: 22.825
- 228: 10/9/18: 0%->5; 4/12/18: 5%->100 / Impacted TSs and TRs: 22.125
- 230: 7/6/18: 0%->15; 6/8/18: 23.742 added;; 10/9/18: 15%->60; 7/12/18: 60%->100 / Impacted TSs and TRs: 23.xxx; 23.742
- 231: 14/3/19: 0%->50 / Impacted TSs and TRs: 23.501; 23.502; 23.503
- 233: Impacted TSs and TRs: 29.507; 29.508; 29.513; 29.512; 29.514; 29.519; 29.520; 29.521; 29.523; 29.525; 29.551; 29.554
- 234: Impacted TSs and TRs: 29.500; 29.501; 29.502; 29.503; 29.504; 29.505; 29.509; 29.510; 29.511; 29.518; 29.531; 29.540; 29.571; 29.572; 29.573
- 235: 16/3/18: 0%->20; 7/6/18: 20%->40; 10/9/18: FCD:09/18->06/19; 2/10/18: WID:SP-171052->SP-180736; 14/3/19: 40%->70 / Impacted TSs and TRs: new 23.794
- 236: Impacted TSs and TRs: 23.501; 23.502; 23.503; 23.228

| ID | WBS | Task | Duration | Start | Finish | Complete | Remaining | Total slack | Constraint | Resources | Work | Actual work | Acronym | PCG approved | WI rapporteur name | WI rapporteur e-mail | Release | TSG approved |
| --- | --- | --- | --- | --- | --- | --- | --- | --- | --- | --- | --- | --- | --- | --- | --- | --- | --- | --- |
| 237 | 139 | **Provision of Access to Restricted Local Operator Services by Unauthenticated UEs** | 791d? | 2016-12-01 A | 2019-12-12 | 54% | 361.97d? | 26091d |  |  | 16600h | 6615.2h | PARLOS | 38 | Covell, Betsy Nokia | betsy.covell@nokia.com | Rel-16 | 76 |
| 238 | 139.1 | Study on Stage 1 of PARLOS | 463d? | 2016-12-01 A | 2018-09-10 A | 100% |  |  | finish no earlier than 2018-09-10 | S1 | 3704h | 3704h | PARLOS | 38 | Covell, Betsy | betsy.covell@nokia.com | Rel-16 | 74 |
| 239 | 139.2 | Stage 1 of PARLOS | 22d? | 2017-05-10 A | 2017-06-08 A | 100% |  |  | finish no earlier than 2017-06-08 | S1 | 176h | 176h | PARLOS | 39 | Covell, Betsy Nokia | betsy.covell@nokia.com | Rel-16 | 76 |
| 240 | 139.3 | Study on Stage 2 for PARLOS | 335d? | 2017-06-05 A | 2018-09-14 A | 100% |  |  | finish no earlier than 2018-09-14 | S2 | 2680h | 2680h | PARLOS | 39 | Nokia (Nicolas Drevon | nicolas.drevon@nokia.com | Rel-16 | 76 |
| 241 | 139.4 | Stage 2 of PARLOS | 137d? | 2018-09-06 A | 2019-03-15 | 95% | 6.85d? | 26285d | finish no earlier than 2019-03-15 | S2 | 1096h |  | PARLOS | 41 | Nokia (Nicolas Drevon | nicolas.drevon@nokia.com) | Rel-16 | 81 |
| 242 | 139.5 | Study on Security Aspects of PARLOS | 138d? | 2018-06-06 A | 2018-12-14 | 50% | 69d? | 26350d | finish no earlier than 2018-12-14 | S3 | 1104h | 55.2h | PARLOS | 41 | Greg Schumacher, Sprint | Gregory.schumacher@sprint.com | Rel-16 | 80 |
| 243 | 139.6 | **CT aspects of PARLOS** | 196d? | 2019-03-14 | 2019-12-12 |  |  | 26091d |  | ct | 7840h |  | PARLOS |  | Liu, Jennifer; Nokia | Jennifer.Liu@nokia.com | Rel-16 |  |
| 244 | 139.6.1 | CT1 aspects of PARLOS | 196d? | 2019-03-14 | 2019-12-12 |  |  | 26091d | finish no earlier than 2019-12-12 | C1 | 1568h |  | PARLOS |  | Liu, Jennifer; Nokia | Jennifer.Liu@nokia.com | Rel-16 |  |
| 245 | 139.6.2 | CT3 aspects of PARLOS | 196d? | 2019-03-14 | 2019-12-12 |  |  | 26091d | finish no earlier than 2019-12-12 | C3 | 1568h |  | PARLOS |  | Liu, Jennifer; Nokia | Jennifer.Liu@nokia.com | Rel-16 |  |
| 246 | 139.6.3 | CT4 aspects of PARLOS | 196d? | 2019-03-14 | 2019-12-12 |  |  | 26091d | finish no earlier than 2019-12-12 | C4 | 1568h |  | PARLOS |  | Liu, Jennifer; Nokia | Jennifer.Liu@nokia.com | Rel-16 |  |
| 247 | 139.6.4 | CT6 aspects of PARLOS | 196d? | 2019-03-14 | 2019-12-12 |  |  | 26091d | finish no earlier than 2019-12-12 | C6 | 1568h |  | PARLOS |  | Liu, Jennifer; Nokia | Jennifer.Liu@nokia.com | Rel-16 |  |
| 248 | 140 | **Stage-3 5GS NAS protocol development** | 266d | 2018-12-13 A | 2019-12-19 | 25% | 199.5d | 26086d |  | C1 | 6384h | 532h | 5GProtoc16 |  | Sedlacek, Ivo, Ericsson | ivo <dot> sedlacek <at> ericsson <dot> com | Rel-16 | 82 |
| 249 | 140.1 | Stage-3 5GS NAS protocol development general aspects | 266d | 2018-12-13 A | 2019-12-19 | 25% | 199.5d | 26086d | start no earlier than 2018-12-13 | C1 | 2128h |  | 5GProtoc16 |  | Sedlacek, Ivo, Ericsson | ivo <dot> sedlacek <at> ericsson <dot> com | Rel-16 | 82 |
| 250 | 140.2 | Stage-3 5GS NAS protocol development for support for non-3GPP accesses | 266d | 2018-12-13 A | 2019-12-19 | 25% | 199.5d | 26086d | start no earlier than 2018-12-13 | C1 | 2128h |  | 5GProtoc16-non3GPP |  | Sedlacek, Ivo, Ericsson | ivo <dot> sedlacek <at> ericsson <dot> com | Rel-16 | 82 |
| 251 | 141 | **Stage-3 SAE Protocol Development for Rel16** | 266d | 2018-12-13 A | 2019-12-19 | 25% | 199.5d | 26086d |  | C1 | 8512h | 532h | SAES16 |  | Aghili, Behrouz, InterDigital Communications | behrouz.aghili@interdigital.com | Rel-16 | 82 |
| 252 | 141.1 | Stage-3 SAE Protocol Development for Rel16 general aspects | 266d | 2018-12-13 A | 2019-12-19 | 25% | 199.5d | 26086d | start no earlier than 2018-12-13 | C1 | 2128h |  | SAES16 |  | Aghili, Behrouz, InterDigital Communications | behrouz.aghili@interdigital.com | Rel-16 | 82 |
| 253 | 141.2 | Stage-3 SAE Protocol Development for Rel16 for CS Fallback in EPS | 266d | 2018-12-13 A | 2019-12-19 | 25% | 199.5d | 26086d | start no earlier than 2018-12-13 | C1 | 2128h |  | SAES16-CSFB |  | Aghili, Behrouz, InterDigital Communications | behrouz.aghili@interdigital.com | Rel-16 | 82 |
| 254 | 141.3 | Stage-3 SAE Protocol Development Rel16 for support for non-3GPP accesses | 266d | 2018-12-13 A | 2019-12-19 | 25% | 199.5d | 26086d | start no earlier than 2018-12-13 | C1 | 2128h |  | SAES16-non3GPP |  | Aghili, Behrouz, InterDigital Communications | behrouz.aghili@interdigital.com | Rel-16 | 82 |
| 255 | 142 | Enhancement of 5G PCC related services | 266d | 2018-12-13 A | 2019-12-19 | 10% | 239.4d | 26086d | start no earlier than 2018-12-13 | C3 | 2128h |  | en5GPccSer |  | Xiaoyun Zhou, Huawei | zhouxiaoyun8@huawei.com | Rel-16 | 82 |
| 256 | 143 | Study on UE power saving in NR | 261d? | 2018-06-15 | 2019-06-15 |  |  | 26220d | finish no earlier than 2019-06-15 | R1 | 2088h |  | FS_NR_UE_pow_sav | 41 | CATT |  | Rel-16 | 80 |
| 257 | 144 | Energy efficiency of 5G | 332d? | 2018-09-06 A | 2019-12-13 | 40% | 199.2d? | 26090d | finish no earlier than 2019-12-13 | S5 | 2656h |  | EE_5G | 41 | CORNILY, Jean-Michel, ORANGE | jeanmichel.cornily@orange.com | Rel-16 | 81 |
| 258 | 145 | Signalling Improvements for Network Efficiency in 5GS | 135d | 2018-12-13 A | 2019-06-19 | 50% | 67.5d | 26217d | start no earlier than 2018-12-13 | C1 | 1080h |  | SINE_5G |  | Shu, Lin | shulin@huawei.com | Rel-16 | 82 |
| 259 | 146 | New Services and Markets Technology Enablers – Phase 2 | 197d? | 2018-03-15 A | 2018-12-14 A | 100% |  |  | finish no earlier than 2018-12-14 | S1 | 1576h | 1576h | SMARTER_Ph2 | 40 | Li, Alice, Vodafone | alice.li@vodafone.com | Rel-16 | 79 |
| 260 | 147 | 5G Voice Service Continuity | 59d? | 2017-12-21 A | 2018-03-13 A | 100% |  |  | finish no earlier than 2018-03-13 | S1 | 472h | 472h | 5GVSC | 40 | Qun Wei, China Unicom | weiqun5@chinaunico.cn | Rel-16 | 78 |
| 261 | 148 | Security Assurance Specification for 5G | 392d? | 2018-03-15 A | 2019-09-13 | 20% | 313.6d? | 26155d | finish no earlier than 2019-09-13 | S3 | 3136h | 313.6h | SCAS_5G | 40 | Marcus Wong, Huawei Technologies | mwong@huawei.com | Rel-16 | 79 |
| 262 | 149 | 5GS Transfer of Policies for Background Data Transfer | 138d? | 2018-06-06 | 2018-12-14 |  |  | 26350d | finish no earlier than 2018-12-14 | S2 | 1104h |  | xBDT | 41 |  | ta-usui@kddi.com | Rel-16 | 80 |

Notes:
- 237: 16/03/18: Moved to Rel-16 as per SA2 chair indication that St 2 work to be shifted from Rel-15 to Rel-16 / Impacted TSs and TRs: 22.115; 22.101; 22.228
- 238: 1/12/16: 0%->75; 2/3/17: 75%->100; 10/9/18: FCD:03/17->09/18 / Impacted TSs and TRs: 22.xxx
- 239: 7/6/17: 0%->100 / Impacted TSs and TRs: 22.115; 22.101; 22.228
- 240: 11/9/17: 0%->20; 16/3/18: FCD:12/17->12/18.; 16/3/18: 20%->45; 23/3/18: WID:SP-170382->SP-180116; 23/3/18: FCD:12/18->06/18; 7/6/18: 45%->70; 15/6/18: WID:SP-180116->SP-180501; 15/6/18: FCD:06/18->09/18; 10/9/18: 70%->100 / Impacted TSs and TRs: 23.715
- 241: 14/3/19: 0%->95 / Impacted TSs and TRs: 23.401; 23.203; 23.221; 23.228; 23.167
- 242: 6/8/18: 33.815 added;; 10/9/18: 0%->5; 7/12/18: 5%->50 / Impacted TSs and TRs: New; 33.815
- 244: Impacted TSs and TRs: 24.301; 24.008; 23.122; 24.368; 24.167; 24.229; 27.007
- 245: Impacted TSs and TRs: 29.212; 29.213; 29.214
- 246: Impacted TSs and TRs: 29.228; 29.229; 29.274
- 247: Impacted TSs and TRs: 31.102; 31.103
- 248: Impacted TSs and TRs: 23.040; 23.041; 23.122; 24.007; 24.008; 24.011; 24.229; 24.301; 24.302; 24.305; 24.368; 24.501; 24.502; 24.526; 27.007
- 249: ; 14/3/19: 0%->25 / Impacted TSs and TRs: 23.040; 23.041; 23.122; 24.007; 24.008; 24.011; 24.229; 24.301; 24.302; 24.305; 24.368; 24.501; 24.502; 24.526; 27.007
- 250: ; 14/3/19: 0%->25 / Impacted TSs and TRs: 23.040; 23.041; 23.122; 24.007; 24.008; 24.011; 24.229; 24.301; 24.302; 24.305; 24.368; 24.501; 24.502; 24.526; 27.007
- 251: Impacted TSs and TRs: 23.122; 24.008; 24.167; 24.229; 24.301; 24.302; 24.303; 24.304; 24.305; 24.312; 29.018; 29.118; 24.368
- 252: 14/3/19: 0%->25 / Impacted TSs and TRs: 23.122; 24.008; 24.167; 24.229; 24.301; 24.302; 24.303; 24.304; 24.305; 24.312; 29.018; 29.118; 24.368
- 253: 14/3/19: 0%->25 / Impacted TSs and TRs: 23.122; 24.008; 24.167; 24.229; 24.301; 24.302; 24.303; 24.304; 24.305; 24.312; 29.018; 29.118; 24.368
- 254: 14/3/19: 0%->25 / Impacted TSs and TRs: 23.122; 24.008; 24.167; 24.229; 24.301; 24.302; 24.303; 24.304; 24.305; 24.312; 29.018; 29.118; 24.368
- 255: ; 14/3/19: 0%->10 / Impacted TSs and TRs: 29.507; 29.512; 29.513; 29.514; 29.551; 29.594; 29.214; 29.519
- 256: TR 38.8xx
- 257: 7/12/18: 0%->20; 14/3/19: 20%->40 / Impacted TSs and TRs: 28.540; 28.541; 28.552; 28.554
- 258: ; 14/3/19: 0%->50 / Impacted TSs and TRs: 24.501; 24.301; 24.368; 27.007; 24.008
- 259: 7/6/18: WID:SP-180138->SP-180313; 7/6/18: 0%->10; 10/9/18: 10%->40; 4/12/18: 40%->100 / Impacted TSs and TRs: 22.261; 22.278
- 260: 16/3/18: 0%->100 / Impacted TSs and TRs: 22.261
- 261: 27/3/18: added: 33.514; 33.513; 33.511; 33.512; 33.515 ; 6/8/18: 33.511 to 515 added;; 10/9/18: 0%->10; 2/10/18: WID:SP-180238->SP-180689; 7/12/18: 10%->20 / Impacted TSs and TRs: 33.216; 33.926; 33.515; 33.511; 33.512; 33.513; 33.514; 33.515
- 262: Impacted TSs and TRs: 23.501; 23.502; 23.503

| ID | WBS | Task | Type | Duration | Start | Finish | Complete | Remaining | Total slack | Constraint | Resources | Work | Actual work | Acronym | PCG approved | WI rapporteur name | WI rapporteur e-mail | Release | TSG approved |
| --- | --- | --- | --- | --- | --- | --- | --- | --- | --- | --- | --- | --- | --- | --- | --- | --- | --- | --- | --- |
| 263 | 150 | **Media Handling Aspects of RAN Delay Budget Reporting in MTSI** |  | 520d? | 2017-12-15 A | 2019-12-12 | 37% | 327.35d? | 26091d |  | S4 | 13576h | 4034.67h | E2E_DELAY | 41 | Oyman, Ozgur, Company: Intel | ozgur.oyman@intel.com | Rel-16 | 81 |
| 264 | 150.1 | Study on E2E_DELAY |  | 196d? | 2017-12-15 A | 2018-09-14 A | 100% |  |  | finish no earlier than 2018-09-14 | S4 | 1568h | 1568h | FS_E2E_DELAY | 40 | Oyman, Ozgur, Company: Intel, | ozgur.oyman@intel.com | Rel-16 | 78 |
| 265 | 150.2 | Stage 2 of E2E_DELAY |  | 197d? | 2018-09-06 A | 2019-06-07 | 85% | 29.55d? | 26225d | finish no earlier than 2019-06-07 | S4 | 1576h |  | E2E_DELAY | 41 | Oyman, Ozgur, Company: Intel | ozgur.oyman@intel.com | Rel-16 | 81 |
| 266 | 150.3 | **CT Aspects of E2E_DELAY** |  | 196d? | 2019-03-14 | 2019-12-12 |  |  | 26091d |  | ct | 6272h |  | E2E_DELAY |  | Luetzenkirchen, Thomas, Intel | Thomas.luetzenkirchen@intel.com | Rel-16 |  |
| 267 | 150.3.1 | CT1 Aspects of E2E_DELAY |  | 196d? | 2019-03-14 | 2019-12-12 |  |  | 26091d | finish no earlier than 2019-12-12 | C1 | 1568h |  | E2E_DELAY |  | Luetzenkirchen, Thomas, Intel | Thomas.luetzenkirchen@intel.com | Rel-16 |  |
| 268 | 150.3.2 | CT3 Aspects of E2E_DELAY |  | 196d? | 2019-03-14 | 2019-12-12 |  |  | 26091d | finish no earlier than 2019-12-12 | C3 | 1568h |  | E2E_DELAY |  | Luetzenkirchen, Thomas, Intel | Thomas.luetzenkirchen@intel.com | Rel-16 |  |
| 269 | 150.3.3 | CT4 Aspects of E2E_DELAY |  | 196d? | 2019-03-14 | 2019-12-12 |  |  | 26091d | finish no earlier than 2019-12-12 | C4 | 1568h |  | E2E_DELAY |  | Luetzenkirchen, Thomas, Intel | Thomas.luetzenkirchen@intel.com | Rel-16 |  |
| 270 | 151 | Enhancements to IMS for new real time communication services |  | 197d? | 2018-03-15 A | 2018-12-14 A | 100% |  |  | finish no earlier than 2018-12-14 | S1 | 1576h | 1576h | enIMS | 40 | China Mobile, Hui Cai | caihui at chinamobile dot com | Rel-16 | 79 |
| 271 | 152 | Service Interactivity |  | 461d? | 2017-09-08 A | 2019-06-14 | 70% | 138.3d? | 26220d | finish no earlier than 2019-06-15 | S4 | 3688h | 1324h | SerInter | 39 | Lo, Charles, Qualcomm Incorporated | clo@qti.qualcomm.com | Rel-16 | 77 |
| 272 | 153 | EVS Codec Extension for Immersive Voice and Audio Services |  | 591d? | 2017-09-08 A | 2019-12-13 | 25% | 443.25d? | 26090d | finish no earlier than 2019-12-13 | S4 | 4728h | 945.6h | IVAS_Codec | 39 | Gibbs, Jon, Huawei Technologies Co Ltd | jon.gibbs@oblisco.com | Rel-16 | 77 |
| 273 | 154 | Alternative EVS implementation using updated fixed-point basic operators |  | 138d? | 2018-06-06 A | 2018-12-14 A | 100% |  |  | finish no earlier than 2018-12-14 | S4 | 1104h | 1104h | Alt_FX_EVS | 41 | Pawate, Raj, Cadence Design Systems Inc | pawateb@cadence.com | Rel-16 | 80 |
| 274 | 155 | Shared Data Handling on Nudm and Nudr |  | 138d? | 2018-06-06 A | 2018-12-14 A | 100% |  |  | finish no earlier than 2018-12-14 | C4 | 1104h | 1104h | Shared_Data | 41 | Wiehe, Ulrich, Nokia | ulrich.wiehe@nokia.com | Rel-16 | 80 |
| 275 | 156 | Usage of CAPIF for xMB API |  | 197d? | 2018-03-15 A | 2018-12-14 A | 100% |  |  | finish no earlier than 2018-12-14 | S4 | 1576h | 1576h | CAPIF4xMB | 40 | Thorsten Lohmar, Ericsson LM | Thorsten.lohmar@ericsson.com | Rel-16 | 79 |
| 276 | 157 | **Enhancements for Common API Framework for 3GPP Northbound APIs** |  | 397d? | 2018-03-15 A | 2019-09-20 | 56% | 173.58d? | 26150d |  |  | 3696h |  | eCAPIF | 40 | Basavaraj Pattan, Samsung | basavarajjp@samsung.com | Rel-16 | 79 |
| 277 | 157.1 | Stage 2 for eCAPIF |  | 325d? | 2018-03-15 A | 2019-06-12 | 80% | 65d? | 26222d | finish no earlier than 2019-06-12 | S6 | 2600h |  | eCAPIF | 40 | Basavaraj Pattan, Samsung | basavarajjp@samsung.com | Rel-16 | 79 |
| 278 | 157.2 | Security aspects of eCAPIF | manual | 137d | 2019-03-14 | 2019-09-20 |  |  |  |  | S3 | 1096h |  | eCAPIF |  | Rajavelsamy Rajadurai, Samsung | rajvel{@]samsung.com | Rel-16 |  |
| 279 | 158 | Study on User Data Interworking, Coexistence and Migration |  | 455d? | 2018-06-15 A | 2020-03-12 A | 100% |  |  | finish no earlier than 2020-03-12 | S2 | 3640h | 3640h | FS_UDICoM | 41 | Susana Sabater (Vodafone | susana.sabater@vodafone.com | Rel-16 | 80 |
| 280 | 159 | User data interworking, Coexistence and Migration | manual | 66.88d | 2019-03-14 | 2019-06-14 |  |  |  |  | S2 | 535h |  | UDICOM |  | Alessio Casati, Nokia | Alessio.casati@nokia.com | Rel-16 |  |
| 281 | 160 | **E-UTRA 2.4 GHz TDD Band for US** |  | 329d? | 2018-03-15 A | 2019-06-18 | 75% | 83.5d? | 26218d |  | R4 | 5800h | 4328.03h | LTE_TDD_2400_US | 40 | Globalstar |  | Rel-16 | 79 |
| 282 | 160.1 | Core part: E-UTRA 2.4 GHz TDD Band for US |  | 197d? | 2018-03-15 A | 2018-12-15 A | 100% |  |  | finish no earlier than 2018-12-15 | R4 | 1576h | 1576h | LTE_TDD_2400_US-Core | 40 | Globalstar |  | Rel-16 | 79 |
| 283 | 160.2 | Perf. part: E-UTRA 2.4 GHz TDD Band for US |  | 197d? | 2018-03-15 A | 2018-12-15 A | 100% |  |  | finish no earlier than 2018-12-15 | R4 | 1576h | 1576h | LTE_TDD_2400_US-Perf | 40 | Globalstar |  | Rel-16 | 79 |
| 284 | 160.3 | UE Conformance Test Aspects - E-UTRA 2.4 GHz TDD Band for US (Band 53) |  | 134d | 2018-12-13 | 2019-06-18 |  |  | 26218d | start no earlier than 2018-12-13 | R5 | 1072h |  | LTE_TDD_2400_US-UEConTest |  | Globalstar |  | Rel-15 | 82 |
| 285 | 161 | Policy delivery to UE for background data transfer |  | 29d? | 2018-05-08 A | 2018-06-15 A | 100% |  |  | start no earlier than 2018-05-08 | S1 | 232h | 232h | PDBDT | 41 | Takatsugu Kito, KDDI | ta-kito at kddi dot com | Rel-16 | 80 |
| 286 | 162 | QoS Monitoring |  | 197d? | 2018-03-15 A | 2018-12-14 A | 100% |  |  | finish no earlier than 2018-12-14 | S1 | 1576h | 1576h | QoS_MON | 40 | Amar Deol | amar.deol@huawei.com | Rel-16 | 79 |
| 287 | 163 | Inter-RAT Mobility requirements for real time service |  | 73d? | 2018-06-06 A | 2018-09-14 A | 100% |  |  | finish no earlier than 2018-09-14 | S1 | 584h | 584h | MOBRT | 41 | Yang Xu, Oppo | xuyang@oppo.com | Rel-16 | 80 |
| 288 | 164 | Management of QoE measurement collection |  | 594d? | 2017-06-05 A | 2019-09-12 | 55% | 267.3d? | 26156d | finish no earlier than 2019-09-12 | S5 | 4752h | 960h | QOED | 39 | Petersen, Robert, Ericsson | robert <dot> petersen <at>ericsson<dot>ericsson | Rel-16 | 76 |

Notes:
- 263: Impacted TSs and TRs: 26.114
- 264: 16/3/18: 0%->10; 7/6/18: 10%->60; 10/9/18: 60%->100 / Impacted TSs and TRs: new
- 265: 7/12/18: 0%->75; 7/3/19: 75%->85; 7/3/19: FCD:03/19->06/19 / Impacted TSs and TRs: 26.114
- 267: Impacted TSs and TRs: 24.229
- 268: Impacted TSs and TRs: 29.162
- 269: Impacted TSs and TRs: 23.334; 29.334; 29.238; 23.333; 29.333
- 270: 7/6/18: 0%->25; 10/9/18: 25%->50; 10/9/18: FCD:09/18->12/18; 4/12/18: 50%->100 / Impacted TSs and TRs: 22.261; 22.468; 22.228; 22.280; 22.281; 22.282; 22.179
- 271: 15/12/17: 0%->10; 16/3/18: 10%->20; 7/6/18: 20%->40; 7/6/18: FCD:06/18->12/18. Moved from Rel-15; 10/9/18: 40%->50; 7/12/18: 50%->60; 7/3/19: 60%->70; 7/3/19: FCD:12/18->06/19 / Impacted TSs and TRs: TS 26.346; TS 26.247; TS 26.347
- 272: 15/12/17: added :26.258; 26.256; 26.255; 26.254; 26.253; 26.251; 26.252; 26.250; 26.997; 15/12/17: 0%->5; 16/3/18: 5%->10; 7/6/18: 10%->15; 10/9/18: 15%->20; 7/3/19: 20%->25 / Impacted TSs and TRs: 26.114, new; 26.258; 26.256; 26.255; 26.254; 26.253; 26.251; 26.252; 26.250; 26.997
- 273: 6/8/18: 26.452 added;; 10/9/18: 0%->20; 7/12/18: 20%->90; 7/3/19: 90%->100 / Impacted TSs and TRs: 26.441; 26.442; 26.444; 26.445; 26.446; 26.447; 26.449; 26.450; 26.451; 26.952; 26.452
- 274: 10/9/18: 0%->90; 10/12/18: 90%->100 / Impacted TSs and TRs: 29.503; 29.505; 29.504
- 275: 7/6/18: 0%->25; 6/8/18: 26.348 added;; 10/9/18: 25%->40; 7/12/18: 40%->100 / Impacted TSs and TRs: 26.346, new; 26.348
- 276: 7/6/18: 0%->15; 10/9/18: 15%->30; 7/12/18: 30%->45; 7/12/18: FCD:12/18->06/19; 13/12/18: WID:SP-180161->SP-181137 / Impacted TSs and TRs: 23.222
- 277: 7/6/18: 0%->15; 10/9/18: 15%->30; 7/12/18: 30%->45; 7/12/18: FCD:12/18->06/19; 13/12/18: WID:SP-180161->SP-181137; 14/3/19: 45%->80 / Impacted TSs and TRs: 23.222
- 278: Impacted TSs and TRs: 33.122
- 279: 10/9/18: 0%->30; 2/10/18: WID:SP-180620->SP-180735; 7/12/18: 30%->80; 14/12/18: FCD:12/18->03/20; 14/3/19: 80%->100 / Impacted TSs and TRs: 23.732
- 280: Impacted TSs and TRs: 23.501; 23.502; 23.228
- 281: new LTE TDD band for 2483.5 to 2495MHz; compare band 41: 2,496-2,69GHz introduced by WI LTE_TDD_2600_US; 6/8/18: 36.791 added;; 16/1/19: WID:RP-180583->RP-182405 / Impacted TSs and TRs: 36.791
- 282: new LTE TDD band for 2483.5 to 2495MHz; compare band 41: 2,496-2,69GHz introduced by WI LTE_TDD_2600_US; 6/8/18: 36.791 added;; 16/1/19: 0%->100 / Impacted TSs and TRs: 36.791
- 283: new LTE TDD band for 2483.5 to 2495MHz; compare band 41: 2,496-2,69GHz introduced by WI LTE_TDD_2600_US; 16/1/19: 0%->100
- 284: tested: REL-15 WI LTE_TDD_2400_US-Core
- 285: 10/9/18: 90%->100 / Impacted TSs and TRs: 22.261
- 286: 7/6/18: 0%->60; 10/9/18: 60%->85; 10/9/18: FCD:06/18->12/18; 4/12/18: 85%->100 / Impacted TSs and TRs: TS 22.261
- 287: 10/9/18: 70%->100 / Impacted TSs and TRs: 22.261
- 288: 30/6/17: 28.309 added;; 30/6/17: 28.308 added;; 30/6/17: 28.307 added;; 30/6/17: 28.406 added;; 11/9/17: 0%->5; 15/12/17: 5%->15; 16/3/18: 15%->25; 7/6/18: FCD:06/18->12/18. 16/6/16: moved from Rel-15; 10/9/18: 25%->30; 7/12/18: 30%->40; 13/12/18: FCD:...; 14/3/19: 40%->55 / Impacted TSs and TRs: 32.101; 32.103; 6 new TS; 28.309; 28.308; 28.307; 28.406; 28.405; 28.404

| ID | WBS | Task | Duration | Start | Finish | Complete | Remaining | Total slack | Constraint | Resources | Work | Actual work | Acronym | WI rapporteur name | Release | TSG approved | PCG approved | Impacted TSs and TRs | WI rapporteur e-mail |
| --- | --- | --- | --- | --- | --- | --- | --- | --- | --- | --- | --- | --- | --- | --- | --- | --- | --- | --- | --- |
| 289 | 165 | **Integrated access and backhaul for NR** | 778d? | 2017-03-15 A | 2020-03-06 | 41% | 457.85d? | 26030d |  |  | 8904h | 3664h | NR_IAB | Qualcomm | Rel-16 | 82 |  |  |  |
| 290 | 165.1 | Study onNR_IAB | 458d? | 2017-03-15 A | 2018-12-14 A | 100% |  |  | finish no earlier than 2018-12-15 | R2 | 3664h | 3664h | FS_NR_IAB | Qualcomm | Rel-16 | 75 | 38 | 38.874 |  |
| 291 | 165.2 | Core part: NR_IAB | 262d | 2019-03-07 | 2020-03-06 |  |  | 26030d |  | R2 | 2096h |  | NR_IAB-Core | Qualcomm | Rel-16 | 82 |  |  |  |
| 292 | 165.3 | Perf. Part: NR_IAB | 262d | 2019-03-07 | 2020-03-06 |  |  | 26030d |  | R4 | 2096h |  | NR_IAB-Perf | Qualcomm | Rel-16 | 82 |  |  |  |
| 293 | 165.4 | Study on Security for NR_IAB | 131d | 2019-03-11 | 2019-09-09 |  |  | 26159d | start no earlier than 2019-03-11 | S3 | 1048h |  | FS_NR_IAB_Sec | Rajavelsamy Rajadurai, Samsung, | Rel-16 |  |  | New | rajvel{@]samsung.com |
| 294 | 166 | **LTE intra-band Carrier Aggregation (CA)** | 526d? | 2018-06-15 | 2020-06-19 |  |  | 25955d |  |  | 59992h |  |  |  | Rel-16 | 80 | 41 |  |  |
| 295 | 166.1 | **Rel-16 LTE intra-band CA for x CC DL/y CC UL including contiguous and non-contiguous spectrum (x>=y)** | 391d? | 2018-06-15 | 2019-12-15 |  |  | 26090d |  | R4 | 9384h |  | LTE_CA_R16_intra | Ericsson | Rel-16 | 80 | 41 |  |  |
| 296 | 166.1.1 | Core part: Rel-16 LTE intra-band CA for x CC DL/y CC UL including contiguous and non-contiguous spectrum (x>=y) | 391d? | 2018-06-15 | 2019-12-13 |  |  | 26090d | start no earlier than 2018-06-15 | R4 | 3128h |  | LTE_CA_R16_intra-Core | Ericsson | Rel-16 | 80 | 41 |  |  |
| 297 | 166.1.2 | Perf. part: Rel-16 LTE intra-band CA for x CC DL/y CC UL including contiguous and non-contiguous spectrum (x>=y) | 391d? | 2018-06-15 | 2019-12-15 |  |  | 26090d | finish no earlier than 2019-12-15 | R4 | 3128h |  | LTE_CA_R16_intra-Perf | Ericsson | Rel-16 | 80 | 41 |  |  |
| 298 | 166.2 | **Rel-16 LTE inter-band CA for 2 bands DL with 1 band UL** | 391d? | 2018-06-15 | 2019-12-15 |  |  | 26090d |  | R4 | 9384h |  | LTE_CA_R16_2BDL_1BUL | Qualcomm | Rel-16 | 80 | 41 |  |  |
| 299 | 166.2.1 | Core part: Rel-16 LTE inter-band CA for 2 bands DL with 1 band UL | 391d? | 2018-06-15 | 2019-12-15 |  |  | 26090d | finish no earlier than 2019-12-15 | R4 | 3128h |  | LTE_CA_R16_2BDL_1BUL-Core | Qualcomm | Rel-16 | 80 | 41 |  |  |
| 300 | 166.2.2 | Perf. part: Rel-16 LTE inter-band CA for 2 bands DL with 1 band UL | 391d? | 2018-06-15 | 2019-12-15 |  |  | 26090d | finish no earlier than 2019-12-15 | R4 | 3128h |  | LTE_CA_R16_2BDL_1BUL-Perf | Qualcomm | Rel-16 | 80 | 41 |  |  |
| 301 | 166.3 | **Rel-16 LTE inter-band CA for 3 bands DL with 1 band UL** | 391d? | 2018-06-15 | 2019-12-15 |  |  | 26090d |  | R4 | 9384h |  | LTE_CA_R16_3BDL_1BUL | Huawei | Rel-16 | 80 | 41 |  |  |
| 302 | 166.3.1 | Core part: Rel-16 LTE inter-band CA for 3 bands DL with 1 band UL | 391d? | 2018-06-15 | 2019-12-15 |  |  | 26090d | finish no earlier than 2019-12-15 | R4 | 3128h |  | LTE_CA_R16_3BDL_1BUL-Core | Huawei | Rel-16 | 80 | 41 |  |  |
| 303 | 166.3.2 | Perf. part: Rel-16 LTE inter-band CA for 3 bands DL with 1 band UL | 391d? | 2018-06-15 | 2019-12-15 |  |  | 26090d | finish no earlier than 2019-12-15 | R4 | 3128h |  | LTE_CA_R16_3BDL_1BUL-Perf | Huawei | Rel-16 | 80 | 41 |  |  |
| 304 | 166.4 | **Rel-16 LTE inter-band CA for x bands DL (x=4, 5) with 1 band UL** | 391d? | 2018-06-15 | 2019-12-15 |  |  | 26090d |  | R4 | 9384h |  | LTE_CA_R16_xBDL_1BUL | Nokia | Rel-16 | 80 | 41 |  |  |
| 305 | 166.4.1 | Core part: Rel-16 LTE inter-band CA for x bands DL (x=4, 5) with 1 band UL | 391d? | 2018-06-15 | 2019-12-15 |  |  | 26090d | finish no earlier than 2019-12-15 | R4 | 3128h |  | LTE_CA_R16_xBDL_1BUL-Core | Nokia | Rel-16 | 80 | 41 |  |  |
| 306 | 166.4.2 | Perf. part: Rel-16 LTE inter-band CA for x bands DL (x=4, 5) with 1 band UL | 391d? | 2018-06-15 | 2019-12-15 |  |  | 26090d | finish no earlier than 2019-12-15 | R4 | 3128h |  | LTE_CA_R16_xBDL_1BUL-Perf | Nokia | Rel-16 | 80 | 41 |  |  |
| 307 | 166.5 | **Rel-16 LTE inter-band CA for 2 bands DL with 2 band UL** | 391d? | 2018-06-15 | 2019-12-15 |  |  | 26090d |  | R4 | 9384h |  | LTE_CA_R16_2BDL_2BUL | Huawei | Rel-16 | 80 | 41 |  |  |
| 308 | 166.5.1 | Core part: Rel-16 LTE inter-band CA for 2 bands DL with 2 band UL | 391d? | 2018-06-15 | 2019-12-15 |  |  | 26090d | finish no earlier than 2019-12-15 | R4 | 3128h |  | LTE_CA_R16_2BDL_2BUL-Core | Huawei | Rel-16 | 80 | 41 |  |  |
| 309 | 166.5.2 | Perf. part: Rel-16 LTE inter-band CA for 2 bands DL with 2 band UL | 391d? | 2018-06-15 | 2019-12-13 |  |  | 26090d | start no earlier than 2018-06-15 | R4 | 3128h |  | LTE_CA_R16_2BDL_2BUL-Perf | Huawei | Rel-16 | 80 | 41 |  |  |
| 310 | 166.6 | **Rel-16 LTE inter-band CA for x bands DL (x= 3, 4, 5) with 2 band UL** | 391d? | 2018-06-15 | 2019-12-15 |  |  | 26090d |  | R4 | 9384h |  | LTE_CA_R16_xBDL_2BUL | LG Electronics | Rel-16 | 80 | 41 |  |  |
| 311 | 166.6.1 | Core part: Rel-16 LTE inter-band CA for x bands DL (x= 3, 4, 5) with 2 band UL | 391d? | 2018-06-15 | 2019-12-13 |  |  | 26090d | start no earlier than 2018-06-15 | R4 | 3128h |  | LTE_CA_R16_xBDL_2BUL-Core | LG Electronics | Rel-16 | 80 | 41 |  |  |
| 312 | 166.6.2 | Perf. part: Rel-16 LTE inter-band CA for x bands DL (x= 3, 4, 5) with 2 band UL | 391d? | 2018-06-15 | 2019-12-15 |  |  | 26090d | finish no earlier than 2019-12-15 | R4 | 3128h |  | LTE_CA_R16_xBDL_2BUL-Perf | LG Electronics | Rel-16 | 80 | 41 |  |  |
| 313 | 166.7 | UE Conformance Test Aspects – Rel-16 LTE CA configurations | 461d? | 2018-09-14 | 2020-06-19 |  |  | 25955d | finish no earlier than 2020-06-19 | R5 | 3688h |  | LTE_CA_R16-UEConTest | Ericsson | Rel-16 | 81 | 41 |  |  |

Notes:
- 289: follow-up WI of REL-16 SI FS_NR_IAB
- 290: TR 38.8XX; 30/6/17: 38.874 added;; 19/9/17: WID: RP-170831->RP-171880; 8/1/18: WID: RP-171880->RP-17229027/3/18: Compl:0%->20%; 27/6/18: Compl:20%->50%; 27/6/18: CD:Fri 15/06/18->Sat 15/12/18;; 16/1/19: 50%->100
- 291: follow-up WI of REL-16 SI FS_NR_IAB
- 295: basket WI; TR 36.716-01-01; 16/1/19: WID:RP-180806->SP-182255
- 296: basket WI; TR 36.716-01-01
- 297: basket WI
- 298: basket WI; TR 36.716-02-01; 16/1/19: WID:RP-181441->RP-182345
- 299: basket WI; TR 36.716-02-01
- 300: basket WI
- 301: basket WI; TR 36.716-03-01; 16/1/19: WID:RP-181436->RP-182553
- 302: basket WI; TR 36.716-03-01
- 303: basket WI
- 304: basket WI; TR 36.716-04-01; 16/1/19: WID:RP-181408->RP-182330
- 305: basket WI; TR 36.716-04-01
- 306: basket WI
- 307: basket WI; TR 36.716-02-02; 16/1/19: WID:RP-181356->RP-182555
- 308: basket WI; TR 36.716-02-02
- 309: basket WI
- 310: basket WI; TR 36.716-00-02; 16/1/19: WID:RP-180778->RP-182301
- 311: basket WI; TR 36.716-00-02
- 312: basket WI
- 313: 16/1/19: WID:RP-181605->RP-182648

| ID | WBS | Task | Duration | Start | Finish | Total slack | Constraint | Resources | Work | PCG approved | Release | TSG approved | Acronym | WI rapporteur name |
| --- | --- | --- | --- | --- | --- | --- | --- | --- | --- | --- | --- | --- | --- | --- |
| 314 | 167 | **Dual Connectivity (EN-DC)** | 391d? | 2018-06-15 | 2019-12-15 | 26090d |  |  | 56304h | 41 | Rel-16 | 80 |  |  |
| 315 | 167.1 | **Dual Connectivity (EN-DC) of 1 LTE band (1UL/1DL) and 1 NR band (1DL/1UL)** | 391d? | 2018-06-15 | 2019-12-15 | 26090d |  | R4 | 9384h | 41 | Rel-16 | 80 | DC_R16_1BLTE_1BNR_2DL2UL | NTT DOCOMO |
| 316 | 167.1.1 | Core part: Dual Connectivity (EN-DC) of 1 LTE band (1UL/1DL) and 1 NR band (1DL/1UL) | 391d? | 2018-06-15 | 2019-12-13 | 26090d | start no earlier than 2018-06-15 | R4 | 3128h | 41 | Rel-16 | 80 | DC_R16_1BLTE_1BNR_2DL2UL-Core | NTT DOCOMO |
| 317 | 167.1.2 | Perf. part: Dual Connectivity (EN-DC) of 1 LTE band (1UL/1DL) and 1 NR band (1DL/1UL) | 391d? | 2018-06-15 | 2019-12-15 | 26090d | finish no earlier than 2019-12-15 | R4 | 3128h | 41 | Rel-16 | 80 | DC_R16_1BLTE_1BNR_2DL2UL-Perf | NTT DOCOMO |
| 318 | 167.2 | **Dual Connectivity (EN-DC) of 2 bands LTE inter-band CA (2DL/1UL) and 1 NR band (1DL/1UL)** | 391d? | 2018-06-15 | 2019-12-15 | 26090d |  | R4 | 9384h | 41 | Rel-16 | 80 | DC_R16_2BLTE_1BNR_3DL2UL | Huawei |
| 319 | 167.2.1 | Core part: Dual Connectivity (EN-DC) of 2 bands LTE inter-band CA (2DL/1UL) and 1 NR band (1DL/1UL) | 391d? | 2018-06-15 | 2019-12-15 | 26090d | finish no earlier than 2019-12-15 | R4 | 3128h | 41 | Rel-16 | 80 | DC_R16_2BLTE_1BNR_3DL2UL-Core | Huawei |
| 320 | 167.2.2 | Perf. part: Dual Connectivity (EN-DC) of 2 bands LTE inter-band CA (2DL/1UL) and 1 NR band (1DL/1UL) | 391d? | 2018-06-15 | 2019-12-15 | 26090d | finish no earlier than 2019-12-15 | R4 | 3128h | 41 | Rel-16 | 80 | DC_R16_2BLTE_1BNR_3DL2UL-Perf | Huawei |
| 321 | 167.3 | **Dual Connectivity (EN-DC) of 3 bands LTE inter-band CA (3DL/1UL) and 1 NR band (1DL/1UL)** | 391d? | 2018-06-15 | 2019-12-15 | 26090d |  | R4 | 9384h | 41 | Rel-16 | 80 | DC_R16_3BLTE_1BNR_4DL2UL | Ericsson |
| 322 | 167.3.1 | Core part: Dual Connectivity (EN-DC) of 3 bands LTE inter-band CA (3DL/1UL) and 1 NR band (1DL/1UL) | 391d? | 2018-06-15 | 2019-12-15 | 26090d | finish no earlier than 2019-12-15 | R4 | 3128h | 41 | Rel-16 | 80 | DC_R16_3BLTE_1BNR_4DL2UL-Core | Ericsson |
| 323 | 167.3.2 | Perf. part: Dual Connectivity (EN-DC) of 3 bands LTE inter-band CA (3DL/1UL) and 1 NR band (1DL/1UL) | 391d? | 2018-06-15 | 2019-12-15 | 26090d | finish no earlier than 2019-12-15 | R4 | 3128h | 41 | Rel-16 | 80 | DC_R16_3BLTE_1BNR_4DL2UL-Perf | Ericsson |
| 324 | 167.4 | **Dual Connectivity (EN-DC) of 4 bands LTE inter-band CA (4DL/1UL) and 1 NR band (1DL/1UL)** | 391d? | 2018-06-15 | 2019-12-15 | 26090d |  | R4 | 9384h | 41 | Rel-16 | 80 | DC_R16_4BLTE_1BNR_5DL2UL | Nokia |
| 325 | 167.4.1 | Core part: Dual Connectivity (EN-DC) of 4 bands LTE inter-band CA (4DL/1UL) and 1 NR band (1DL/1UL) | 391d? | 2018-06-15 | 2019-12-15 | 26090d | finish no earlier than 2019-12-15 | R4 | 3128h | 41 | Rel-16 | 80 | DC_R16_4BLTE_1BNR_5DL2UL-Core | Nokia |
| 326 | 167.4.2 | Perf. part: Dual Connectivity (EN-DC) of 4 bands LTE inter-band CA (4DL/1UL) and 1 NR band (1DL/1UL) | 391d? | 2018-06-15 | 2019-12-15 | 26090d | finish no earlier than 2019-12-15 | R4 | 3128h | 41 | Rel-16 | 80 | DC_R16_4BLTE_1BNR_5DL2UL-Perf | Nokia |
| 327 | 167.5 | **Dual Connectivity (EN-DC) of 5 bands LTE inter-band CA (5DL/1UL) and 1 NR band (1DL/1UL)** | 391d? | 2018-06-15 | 2019-12-15 | 26090d |  | R4 | 9384h | 41 | Rel-16 | 80 | DC_R16_5BLTE_1BNR_6DL2UL | Samsung |
| 328 | 167.5.1 | Core part: Dual Connectivity (EN-DC) of 5 bands LTE inter-band CA (5DL/1UL) and 1 NR band (1DL/1UL) | 391d? | 2018-06-15 | 2019-12-15 | 26090d | finish no earlier than 2019-12-15 | R4 | 3128h | 41 | Rel-16 | 80 | DC_R16_5BLTE_1BNR_6DL2UL-Core | Samsung |
| 329 | 167.5.2 | Perf. part: Dual Connectivity (EN-DC) of 5 bands LTE inter-band CA (5DL/1UL) and 1 NR band (1DL/1UL) | 391d? | 2018-06-15 | 2019-12-15 | 26090d | finish no earlier than 2019-12-15 | R4 | 3128h | 41 | Rel-16 | 80 | DC_R16_5BLTE_1BNR_6DL2UL-Perf | Samsung |
| 330 | 167.6 | **Dual Connectivity (EN-DC) of x bands (x=1, 2, 3, 4) LTE inter-band CA (xDL/1UL) and 2 bands NR inter-band CA (2DL/1UL)** | 391d? | 2018-06-15 | 2019-12-15 | 26090d |  | R4 | 9384h | 41 | Rel-16 | 80 | DC_R16_xBLTE_2BNR_yDL2UL | LG Electronics |
| 331 | 167.6.1 | Core part: Dual Connectivity (EN-DC) of x bands (x=2, 3, 4) LTE inter-band CA (xDL/1UL) and 2 bands NR inter-band CA (2DL/1UL) | 391d? | 2018-06-15 | 2019-12-15 | 26090d | finish no earlier than 2019-12-15 | R4 | 3128h | 41 | Rel-16 | 80 | DC_R16_xBLTE_2BNR_yDL2UL-Core | LG Electronics |
| 332 | 167.6.2 | Perf. part: Dual Connectivity (EN-DC) of x bands (x=2, 3, 4) LTE inter-band CA (xDL/1UL) and 2 bands NR inter-band CA (2DL/1UL) | 391d? | 2018-06-15 | 2019-12-15 | 26090d | finish no earlier than 2019-12-15 | R4 | 3128h | 41 | Rel-16 | 80 | DC_R16_xBLTE_2BNR_yDL2UL-Perf | LG Electronics |
| 333 | 168 | **Band combinations for SA NR supplementary uplink (SUL), NSA NR SUL, NSA NR SUL with UL sharing from the UE perspective (ULSUP)** | 391d? | 2018-06-15 | 2019-12-15 | 26090d |  | R4 | 9384h | 41 | Rel-16 | 80 | NR_SUL_combos_R16 | Huawei |
| 334 | 168.1 | Core part: Band combinations for SA NR supplementary uplink (SUL), NSA NR SUL, NSA NR SUL with UL sharing from the UE perspective (ULSUP) | 391d? | 2018-06-15 | 2019-12-15 | 26090d | finish no earlier than 2019-12-15 | R4 | 3128h | 41 | Rel-16 | 80 | NR_SUL_combos_R16-Core | Huawei |
| 335 | 168.2 | Perf. part: Band combinations for SA NR supplementary uplink (SUL), NSA NR SUL, NSA NR SUL with UL sharing from the UE perspective (ULSUP) | 391d? | 2018-06-15 | 2019-12-15 | 26090d | finish no earlier than 2019-12-15 | R4 | 3128h | 41 | Rel-16 | 80 | NR_SUL_combos_R16-Perf | Huawei |
| 336 | 169 | **NR intra band Carrier Aggregation** | 391d? | 2018-06-15 | 2019-12-15 | 26090d |  |  | 18768h | 41 | Rel-16 | 80 |  |  |
| 337 | 169.1 | **Rel-16 NR intra band CA for xCC DL/yCC UL including contiguous and non-contiguous spectrum (x>=y)** | 391d? | 2018-06-15 | 2019-12-15 | 26090d |  | R4 | 9384h | 41 | Rel-16 | 80 | NR_CA_R16_intra | Ericsson |
| 338 | 169.1.1 | Core part: Rel-16 NR intra band CA for xCC DL/yCC UL including contiguous and non-contiguous spectrum (x>=y) | 391d? | 2018-06-15 | 2019-12-15 | 26090d | finish no earlier than 2019-12-15 | R4 | 3128h | 41 | Rel-16 | 80 | NR_CA_R16_intra-Core | Ericsson |
| 339 | 169.1.2 | Perf. part: Rel-16 NR intra band CA for xCC DL/yCC UL including contiguous and non-contiguous spectrum (x>=y) | 391d? | 2018-06-15 | 2019-12-15 | 26090d | finish no earlier than 2019-12-15 | R4 | 3128h | 41 | Rel-16 | 80 | NR_CA_R16_intra-Perf | Ericsson |

Notes:
- 315: basket WI; TR 37.716-01-01; 16/1/19: WID:RP-181447->RP-182567
- 316: basket WI; TR 37.716-01-01
- 317: basket WI
- 318: basket WI; TR 37.716-02-01; 16/1/19: WID:RP-181357->RP-182557
- 319: basket WI; TR 37.716-02-01
- 320: basket WI
- 321: basket WI; TR 37.716-03-01; 16/1/19: WID:RP-181407->RP-182257
- 322: basket WI; TR 37.716-03-01
- 323: basket WI
- 324: basket WI; TR 37.716-04-01; 16/1/19: WID:RP-181001->RP-182534
- 325: basket WI; TR 37.716-04-01
- 326: basket WI
- 327: basket WI; TR 37.716-05-01
- 328: basket WI; TR 37.716-05-01
- 329: basket WI
- 330: basket WI; TR 37.716-00-02; 16/1/19: WID:RP-180777->RP-182302, "x=1" added
- 331: basket WI; TR 37.716-00-02
- 332: basket WI
- 333: basket WI; TR 37.716-00-00; note: WI covers for SA NR: 1 NR SUL band (already defined) + 1 or more NR bands and for NSA NR: 1 NR SUL band (already defined) + 1 or more NR bands + 1 or more LTE bands
- 334: basket WI; TR 37.716-00-00; note: WI covers for SA NR: 1 NR SUL band (already defined) + 1 or more NR bands and for NSA NR: 1 NR SUL band (already defined) + 1 or more NR bands + 1 or more LTE bands
- 335: basket WI
- 337: basket WI; TR 38.716-01-01; 16/1/19: WID:RP-181426->RP-182256
- 338: basket WI; TR 38.716-01-01
- 339: basket WI

| ID | WBS | Task | Duration | Start | Finish | Total slack | Free slack | Constraint | Resources | Work | Actual work | Acronym | PCG approved | WI rapporteur name | Release | TSG approved |
| --- | --- | --- | --- | --- | --- | --- | --- | --- | --- | --- | --- | --- | --- | --- | --- | --- |
| 340 | 169.2 | **Rel-16 NR inter-band CA/Dual Connectivity for 2 bands DL with x bands UL (x=1, 2)** | 391d? | 2018-06-15 | 2019-12-15 | 26090d |  |  | R4 | 9384h |  | NR_CADC_R16_2BDL_xBUL | 41 | ZTE | Rel-16 | 80 |
| 341 | 169.2.1 | Core part: Rel-16 NR inter-band CA/Dual Connectivity for 2 bands DL with x bands UL (x=1, 2) | 391d? | 2018-06-15 | 2019-12-15 | 26090d |  | finish no earlier than 2019-12-15 | R4 | 3128h |  | NR_CADC_R16_2BDL_xBUL-Core | 41 | ZTE | Rel-16 | 80 |
| 342 | 169.2.2 | Perf. part: Rel-16 NR inter-band CA/Dual Connectivity for 2 bands DL with x bands UL (x=1, 2) | 391d? | 2018-06-15 | 2019-12-15 | 26090d |  | finish no earlier than 2019-12-15 | R4 | 3128h |  | NR_CADC_R16_2BDL_xBUL-Perf | 41 | ZTE | Rel-16 | 80 |
| 343 | 170 | **Additional LTE bands** | 391d? | 2018-06-15 | 2019-12-15 | 26090d |  |  |  | 15640h |  |  | 41 |  | Rel-16 | 80 |
| 344 | 170.1 | **Additional LTE bands for UE category M1 and/or NB1 in Rel-16** | 391d? | 2018-06-15 | 2019-12-15 | 26090d |  |  | R4 | 9384h |  | LTE_bands_R16_M1_NB1 | 41 | Ericsson | Rel-16 | 80 |
| 345 | 170.1.1 | Core part: Additional LTE bands for UE category M1 and/or NB1 in Rel-16 | 391d? | 2018-06-15 | 2019-12-15 | 26090d |  | finish no earlier than 2019-12-15 | R4 | 3128h |  | LTE_bands_R16_M1_NB1-Core | 41 | Ericsson | Rel-16 | 80 |
| 346 | 170.1.2 | Perf. part: Additional LTE bands for UE category M1 and/or NB1 in Rel-16 | 391d? | 2018-06-15 | 2019-12-15 | 26090d |  | finish no earlier than 2019-12-15 | R4 | 3128h |  | LTE_bands_R16_M1_NB1-Perf | 41 | Ericsson | Rel-16 | 80 |
| 347 | 170.2 | **Additional LTE bands for UE category M2 and/or NB2 in Rel-16** | 391d? | 2018-06-15 | 2019-12-15 | 26090d |  |  | R4 | 6256h |  | LTE_bands_R16_M2_NB2 | 41 | Ericsson | Rel-16 | 80 |
| 348 | 170.2.1 | Core part: Additional LTE bands for UE category M2 and/or NB2 in Rel-16 | 391d? | 2018-06-15 | 2019-12-15 | 26090d |  | finish no earlier than 2019-12-15 | R4 | 3128h |  | LTE_bands_R16_M2_NB2-Core | 41 | Ericsson | Rel-16 | 80 |
| 349 | 171 | **Band 65 for New Radio** | 131d? | 2018-06-15 | 2018-12-15 | 0d | 26350d |  | R4 | 3144h | 1048h | NR_band_n65 | 41 | Dish Network | Rel-16 | 80 |
| 350 | 171.1 | Core part: Band 65 for New Radio | 131d? | 2018-06-15 | 2018-12-15 | 26350d |  | finish no earlier than 2018-12-15 | R4 | 1048h |  | NR_band_n65-Core | 41 | Dish Network | Rel-16 | 80 |
| 351 | 171.2 | Perf. part: Band 65 for New Radio | 131d? | 2018-06-15 | 2018-12-15 | 26350d |  | finish no earlier than 2018-12-15 | R4 | 1048h |  | NR_band_n65-Perf | 41 | Dish Network | Rel-16 | 80 |
| 352 | 172 | **29 dBm UE Power Class for LTE band 41 and NR Band n41** | 261d? | 2018-06-15 | 2019-06-15 | 26220d |  |  | R4 | 4176h |  | LTE_NR_B41_Bn41_PC29dBm | 41 | Sprint | Rel-16 | 80 |
| 353 | 172.1 | Core part: 29 dBm UE Power Class for LTE band 41 and NR Band n41 | 261d? | 2018-06-15 | 2019-06-15 | 26220d |  | finish no earlier than 2019-06-15 | R4 | 2088h |  | LTE_NR_B41_Bn41_PC29dBm-Core | 41 | Sprint | Rel-16 | 80 |
| 354 | 173 | **Further performance enhancement for LTE in high speed scenario** | 391d? | 2018-06-15 | 2019-12-15 | 26090d |  |  | R4 | 9384h |  | LTE_high_speed_enh2 | 41 | NTT DOCOMO | Rel-16 | 80 |
| 355 | 173.1 | Core part: Further performance enhancement for LTE in high speed scenario | 391d? | 2018-06-15 | 2019-12-15 | 26090d |  | finish no earlier than 2019-12-15 | R4 | 3128h |  | LTE_high_speed_enh2-Core | 41 | NTT DOCOMO | Rel-16 | 80 |
| 356 | 173.2 | Perf. part: Further performance enhancement for LTE in high speed scenario | 391d? | 2018-06-15 | 2019-12-15 | 26090d |  | finish no earlier than 2019-12-15 | R4 | 3128h |  | LTE_high_speed_enh2-Perf | 41 | NTT DOCOMO | Rel-16 | 80 |
| 357 | 174 | **Cross Link Interference (CLI) handling and Remote Interference Management (RIM) for NR** | 261d? | 2018-06-15 | 2019-06-15 | 26220d |  |  | R1 | 6264h |  | NR_CLI_RIM | 41 | LG Electronics | Rel-16 | 80 |
| 358 | 174.1 | Core part: Cross Link Interference (CLI) handling and Remote Interference Management (RIM) for NR | 261d? | 2018-06-15 | 2019-06-15 | 26220d |  | finish no earlier than 2019-06-15 | R1 | 2088h |  | NR_CLI_RIM-Core | 41 | LG Electronics | Rel-16 | 80 |
| 359 | 174.2 | Perf. part: Cross Link Interference (CLI) handling and Remote Interference Management (RIM) for NR | 261d? | 2018-06-15 | 2019-06-15 | 26220d |  | finish no earlier than 2019-06-15 | R4 | 2088h |  | NR_CLI_RIM-Perf | 41 | LG Electronics | Rel-16 | 80 |
| 360 | 175 | **Enhancements on MIMO for NR** | 588d? | 2018-06-15 | 2020-09-15 | 25893d |  |  | R1 | 12536h |  | NR_eMIMO | 41 | Samsung | Rel-16 | 80 |
| 361 | 175.1 | Core part: Enhancements on MIMO for NR | 391d? | 2018-06-15 | 2019-12-15 | 26090d |  | finish no earlier than 2019-12-15 | R1 | 3128h |  | NR_eMIMO-Core | 41 | Samsung | Rel-16 | 80 |
| 362 | 175.2 | Perf. part: Enhancements on MIMO for NR | 588d? | 2018-06-15 | 2020-09-15 | 25893d |  | finish no earlier than 2020-09-15 | R4 | 4704h |  | NR_eMIMO-Perf | 41 | Samsung | Rel-16 | 80 |
| 363 | 176 | **DL MIMO efficiency enhancements for LTE** | 391d? | 2018-06-15 | 2019-12-15 | 26090d |  |  | R1 | 9384h |  | LTE_DL_MIMO_EE | 41 | Huawei | Rel-16 | 80 |
| 364 | 176.1 | Core part: DL MIMO efficiency enhancements for LTE | 391d? | 2018-06-15 | 2019-12-15 | 26090d |  | finish no earlier than 2019-12-15 | R1 | 3128h |  | LTE_DL_MIMO_EE-Core | 41 | Huawei | Rel-16 | 80 |
| 365 | 176.2 | Perf. part: DL MIMO efficiency enhancements for LTE | 391d? | 2018-06-15 | 2019-12-15 | 26090d |  | finish no earlier than 2019-12-15 | R4 | 3128h |  | LTE_DL_MIMO_EE-Perf | 41 | Huawei | Rel-16 | 80 |

Notes:
- 340: basket WI; TR 38.716-02-00; 16/1/19: WID:RP-180817->RP-182501
- 341: basket WI; TR 38.716-02-00
- 342: basket WI
- 344: basket WI; 16/1/19: WID:RP-181006->RP-182768
- 345: basket WI
- 346: basket WI
- 347: basket WI; no Perf. part; 16/1/19: WID:RP-181007->RP-182769
- 348: basket WI; no Perf. part
- 349: 16/1/19: WID:RP-181445->RP-182258
- 352: no Perf. part
- 353: no Perf. part; 7/3/19: WID:RP-181460->RP-181655
- 357: 16/1/19: WID:RP-181431->RP-182864
- 360: 16/1/19: WID:RP-181453->RP-182863
- 363: 16/1/19: WID:RP-181485->RP-182901

| ID | WBS | Task | Type | Duration | Start | Finish | Total slack | Constraint | Resources | Work | Acronym | PCG approved | WI rapporteur name | Release | TSG approved |
| --- | --- | --- | --- | --- | --- | --- | --- | --- | --- | --- | --- | --- | --- | --- | --- |
| 366 | 177 | **NR mobility enhancements** |  | 391d? | 2018-06-15 | 2019-12-15 | 26090d |  | R2 | 9384h | NR_Mob_enh | 41 | Intel | Rel-16 | 80 |
| 367 | 177.1 | Core part: NR mobility enhancements |  | 391d? | 2018-06-15 | 2019-12-15 | 26090d | finish no earlier than 2019-12-15 | R2 | 3128h | NR_Mob_enh-Core | 41 | Intel | Rel-16 | 80 |
| 368 | 177.2 | Perf. part: NR mobility enhancements |  | 391d? | 2018-06-15 | 2019-12-15 | 26090d | finish no earlier than 2019-12-15 | R4 | 3128h | NR_Mob_enh-Perf | 41 | Intel | Rel-16 | 80 |
| 369 | 178 | **LTE-NR & NR-NR Dual Connectivity and NR Carrier Aggregation enhancements** |  | 522d? | 2018-06-15 | 2020-06-15 | 25959d |  | R2 | 11480h | LTE_NR_DC_CA_enh | 41 | Ericsson | Rel-16 | 80 |
| 370 | 178.1 | Core part: LTE-NR & NR-NR Dual Connectivity and NR CA enhancements |  | 391d? | 2018-06-15 | 2019-12-15 | 26090d | finish no earlier than 2019-12-15 | R2 | 3128h | LTE_NR_DC_CA_enh-Core | 41 | Ericsson | Rel-16 | 80 |
| 371 | 178.2 | Perf. part: LTE-NR & NR-NR Dual Connectivity and NR CA enhancements |  | 522d? | 2018-06-15 | 2020-06-15 | 25959d | finish no earlier than 2020-06-15 | R4 | 4176h | LTE_NR_DC_CA_enh-Perf | 41 | Ericsson | Rel-16 | 80 |
| 372 | 179 | **2-step RACH for NR** |  | 262d | 2018-12-15 | 2019-12-15 |  |  | R1 | 5272h | NR_2step_RACH |  | ZTE | Rel-16 | 82 |
| 373 | 179.1 | Core part: 2-step RACH for NR | manual | 262d | 2018-12-15 | 2019-12-15 |  |  | R1 | 2096h | NR_2step_RACH-Core |  | ZTE | Rel-16 | 82 |
| 374 | 179.2 | Perf. part: 2-step RACH for NR | manual | 135d | 2018-12-15 | 2019-06-20 |  |  | R4 | 1080h | NR_2step_RACH-Perf |  | ZTE | Rel-16 | 82 |
| 375 | 180 | **Single Radio Voice Call Continuity from 5G to 3G** |  | 262d | 2018-12-15 | 2019-12-15 |  |  | R2 | 4192h | SRVCC_NR_to_UMTS |  | China Unicom | Rel-16 | 82 |
| 376 | 180.1 | Core part: Single Radio Voice Call Continuity from 5G to 3G | manual | 262d | 2018-12-15 | 2019-12-15 |  |  | R2 | 2096h | SRVCC_NR_to_UMTS-Core |  | China Unicom | Rel-16 | 82 |
| 377 | 181 | **Transfer of Iuant interface specifications from 25-series to 37-series** |  | 68d | 2018-12-13 | 2019-03-18 | 26284d |  | R3 | 1088h | Iuant_transfer |  | Huawei | Rel-16 | 82 |
| 378 | 181.1 | Core part: Transfer of Iuant interface specifications from 25-series to 37-series |  | 68d | 2018-12-13 | 2019-03-18 | 26284d | start no earlier than 2018-12-13 | R3 | 544h | Iuant_transfer-Core |  | Huawei | Rel-16 | 82 |
| 379 | 182 | **Direct data forwarding between NG-RAN and E-UTRAN nodes for inter-system mobility** |  | 134d | 2018-12-13 | 2019-06-18 | 26218d |  | R3 | 2144h | Direct_data_fw_NR |  | Ericsson | Rel-16 | 82 |
| 380 | 182.1 | Core part: Direct data forwarding between NG-RAN and E-UTRAN nodes for inter-system mobility |  | 134d | 2018-12-13 | 2019-06-18 | 26218d | start no earlier than 2018-12-13 | R3 | 1072h | Direct_data_fw_NR-Core |  | Ericsson | Rel-16 | 82 |
| 381 | 183 | **Introduction of NR band n18** |  | 262d | 2018-12-13 | 2019-12-13 | 26090d |  | R4 | 6288h | NR_n18 |  | KDDI | Rel-16 | 82 |
| 382 | 183.1 | Core part: Introduction of NR band n18 |  | 262d | 2018-12-13 | 2019-12-13 | 26090d | start no earlier than 2018-12-13 | R4 | 2096h | NR_n18-Core |  | KDDI | Rel-16 | 82 |
| 383 | 183.2 | Perf. part: Introduction of NR band n18 |  | 262d | 2018-12-13 | 2019-12-13 | 26090d | start no earlier than 2018-12-13 | R4 | 2096h | NR_n18-Perf |  | KDDI | Rel-16 | 82 |
| 384 | 184 | **Adding wider channel bandwidths in NR band n7** |  | 197d | 2018-12-13 | 2019-09-13 | 26155d |  | R4 | 3152h | NR_n7_BW |  | BT | Rel-16 | 82 |
| 385 | 184.1 | Core part: Adding wider channel bandwidths in NR band n7 |  | 197d | 2018-12-13 | 2019-09-13 | 26155d | start no earlier than 2018-12-13 | R4 | 1576h | NR_n7_BW-Core |  | BT | Rel-16 | 82 |
| 386 | 185 | **Addition of 30MHz channel bandwidth for NR band n41** |  | 134d | 2018-12-13 | 2019-06-18 | 26218d |  | R4 | 3216h | NR_n41_BW |  | KDDI | Rel-16 | 82 |
| 387 | 185.1 | Core part: Addition of 30MHz channel bandwidth for NR band n41 |  | 134d | 2018-12-13 | 2019-06-18 | 26218d | start no earlier than 2018-12-13 | R4 | 1072h | NR_n41_BW-Core |  | KDDI | Rel-16 | 82 |
| 388 | 185.2 | Perf. part: Addition of 30MHz channel bandwidth for NR band n41 |  | 134d | 2018-12-13 | 2019-06-18 | 26218d | start no earlier than 2018-12-13 | R4 | 1072h | NR_n41_BW-Perf |  | KDDI | Rel-16 | 82 |
| 389 | 186 | **Adding wider channel bandwidths in NR band n50** |  | 134d | 2018-12-13 | 2019-06-18 | 26218d |  | R4 | 2144h | NR_n50_BW |  | Huawei | Rel-16 | 82 |
| 390 | 186.1 | Core part: Adding wider channel bandwidths in NR band n50 |  | 134d | 2018-12-13 | 2019-06-18 | 26218d | start no earlier than 2018-12-13 | R4 | 1072h | NR_n50_BW-Core |  | Huawei | Rel-16 | 82 |

Notes:
- 369: RAN3 impact?
- 370: RAN3 impact?
- 372: WI was created after REL-16 SI FS_NR_NOMA was completed
- 373: WI was created after REL-16 SI FS_NR_NOMA was completed
- 375: no Perf. part
- 376: no Perf. part
- 377: administrative WI that transfers REL-8 to REL-15 25.46x specs (formerly created for UMTS, later misused for LTE and recently extended to NR) into 37 series specs affecting UMTS, LTE and NR turning 25.46x specs into pointers to 37 series specs; no Perf. pa
- 378: administrative WI that transfers REL-8 to REL-15 25.46x specs (formerly created for UMTS, later misused for LTE and recently extended to NR) into 37 series specs affecting UMTS, LTE and NR turning 25.46x specs into pointers to 37 series specs; no Perf. pa
- 379: no Perf. part
- 380: no Perf. part
- 384: no Perf. part
- 385: no Perf. part
- 389: no Perf. part
- 390: no Perf. part

| ID | WBS | Task | Duration | Start | Finish | Complete | Remaining | Total slack | Constraint | Resources | Work | Actual work | Acronym | WI rapporteur name | Release | TSG approved | PCG approved | WI rapporteur e-mail |
| --- | --- | --- | --- | --- | --- | --- | --- | --- | --- | --- | --- | --- | --- | --- | --- | --- | --- | --- |
| 391 | 187 | **Introduction of NR band n48** | 68d | 2018-12-13 | 2019-03-18 |  |  | 26284d |  | R4 | 1088h |  | NR_n48 | US Cellular | Rel-16 | 82 |  |  |
| 392 | 187.1 | Core part: Introduction of NR band n48 | 68d | 2018-12-13 | 2019-03-18 |  |  | 26284d | start no earlier than 2018-12-13 | R4 | 544h |  | NR_n48-Core | US Cellular | Rel-16 | 82 |  |  |
| 393 | 188 | **Even further mobility enhancement in E-UTRAN** | 391d? | 2018-06-15 | 2019-12-15 |  |  | 26090d |  | R2 | 9384h |  | LTE_feMob | China Telecom | Rel-16 | 80 | 41 |  |
| 394 | 188.1 | Core part: Even further mobility enhancement in E-UTRAN | 391d? | 2018-06-15 | 2019-12-15 |  |  | 26090d | finish no earlier than 2019-12-15 | R2 | 3128h |  | LTE_feMob-Core | China Telecom | Rel-16 | 80 | 41 |  |
| 395 | 188.2 | Perf. part: Even further mobility enhancement in E-UTRAN | 391d? | 2018-06-15 | 2019-12-15 |  |  | 26090d | finish no earlier than 2019-12-15 | R4 | 3128h |  | LTE_feMob-Perf | China Telecom | Rel-16 | 80 | 41 |  |
| 396 | 189 | **eNB(s) Architecture Evolution for E-UTRAN and NG-RAN** | 457d? | 2018-03-15 A | 2019-12-13 | 15% | 388.45d? | 26090d |  | R3 | 7312h | 1096.8h | LTE_NR_arch_evo | China Unicom | Rel-16 | 79 | 40 |  |
| 397 | 189.1 | Core part: eNB(s) Architecture Evolution for E-UTRAN and NG-RAN | 457d? | 2018-03-15 A | 2019-12-13 | 15% | 388.45d? | 26090d | finish no earlier than 2019-12-15 | R3 | 3656h | 548.4h | LTE_NR_arch_evo-Core | China Unicom | Rel-16 | 79 | 40 |  |
| 398 | 190 | Volume Based Charging Aspects for VoLTE | 202d? | 2018-09-06 A | 2019-06-14 | 50% | 101d? | 26220d | finish no earlier than 2019-06-14 | S5 | 1616h |  | VBCLTE | Chen, Ai, China Mobile | Rel-16 | 81 | 41 | chenai@chinamobile.com |
| 399 | 191 | Study on network policy management for mobile networks based on NFV scenarios | 269d? | 2017-06-05 A | 2018-06-14 A | 100% |  |  | finish no earlier than 2018-06-14 | S5 | 2152h | 2152h | FS_NETPOL | China Mobile Jinglei Liu | Rel-15 | 76 | 39 | liujinglei@chinamobile.com |
| 400 | 192 | Network policy management for mobile networks based on NFV scenarios | 267d? | 2018-09-06 A | 2019-09-13 | 10% | 240.3d? | 26155d | finish no earlier than 2019-09-13 | S5 | 2136h |  | NETPOL | China Mobile Hao Zhang | Rel-16 | 81 | 41 | zhanghao@chinamobile.com |
| 401 | 193 | Intent driven management service for mobile network | 202d? | 2018-09-06 A | 2019-06-14 | 30% | 141.4d? | 26220d | finish no earlier than 2019-06-14 | S5 | 1616h |  | IDMS_MN | Zou Lan, Huawei | Rel-16 | 81 | 41 | zoulan@huawei.com |
| 402 | 194 | OAM aspects of LTE and WLAN integration | 202d? | 2018-09-06 A | 2019-06-14 A | 100% |  |  | finish no earlier than 2019-06-14 | S5 | 1616h | 1616h | OAM_LTE_WLAN | Yizhi Yao, Intel Corporation | Rel-16 | 81 | 41 | yizhi dot yao at intel dot com |
| 403 | 195 | Methodology for 5G management specifications | 137d? | 2018-09-06 A | 2019-03-15 | 85% | 20.55d? | 26285d | finish no earlier than 2019-03-15 | S5 | 1096h |  | METHOGY | Groenendijk, Jan, Ericsson | Rel-16 | 81 | 41 | jan<dot>Groenendijk<at>ericsson<dot>com |
| 404 | 196 | Nchf Online and Offline charging services | 201d | 2018-12-13 A | 2019-09-19 | 40% | 120.6d | 26151d | start no earlier than 2018-12-13 | S5 | 1608h |  | OFSBI_CH | Zhu Lei, Huawei | Rel-16 | 82 |  | Zhulei@huawei.com |
| 405 | 197 | Charging Enhancement of 5GC interworking with EPC | 201d | 2018-12-13 A | 2019-09-19 | 30% | 140.7d | 26151d | start no earlier than 2018-12-13 | S5 | 1608h |  | 5GIEPC_CH | Chen Shan, Huawei | Rel-16 | 82 |  | chenshan@huawei.com |
| 406 | 198 | NRM enhancements | 135d | 2018-12-13 A | 2019-06-19 | 10% | 121.5d | 26217d | start no earlier than 2018-12-13 | S5 | 1080h |  | eNRM | Jing Ping, Nokia | Rel-16 | 82 |  | jing.ping@nokia-sbell.com |
| 407 | 199 | Network Exposure Charging in 5G System Architecture | 266d | 2018-12-13 A | 2019-12-19 | 20% | 212.8d | 26086d | start no earlier than 2018-12-13 | S5 | 2128h |  | 5GS_Ph1_NEFCH | Tornkvist, Robert, Ericsson | Rel-16 | 82 |  | robert(dot)tornkvist(at)Ericsson(dot)com |
| 408 | 200 | Charging AMF in 5G System Architecture Phase 1 | 266d | 2018-12-13 A | 2019-12-19 | 20% | 212.8d | 26086d | start no earlier than 2018-12-13 | S5 | 2128h |  | 5GS_Ph1_AMFCH | Gardella, Maryse, Nokia | Rel-16 | 82 |  | maryse.gardella@nokia.com |
| 409 | 201 | Discovery of management services in 5G | 135d | 2018-12-13 A | 2019-06-19 | 25% | 101.25d | 26217d | start no earlier than 2018-12-13 | S5 | 1080h |  | 5GDMS | Attila Horvat, Huawei Technologies Sweden AB | Rel-16 | 82 |  | attila.horvat@huawei.com |
| 410 | 202 | Trace Management in the context of Services Based Management Architecture | 135d | 2018-12-13 | 2019-06-19 |  |  | 26217d | start no earlier than 2018-12-13 | S5 | 1080h |  | TM_SBMA | Andrianov, Anatoly, Nokia | Rel-16 | 82 |  | anatoly.andrianov@nokia.com |
| 411 | 203 | Lawful Interception Rel-16 | 266d | 2018-12-13 | 2019-12-19 |  |  | 26086d | start no earlier than 2018-12-13 | S3LI | 2128h |  | LI16 | Alex Leadbeater, BT | Rel-16 | 82 |  | alex.leadbeater@bt.com |
| 412 | 204 | IMS Stage-3 IETF Protocol Alignment | 266d | 2018-12-13 A | 2019-12-19 | 25% | 199.5d | 26086d | start no earlier than 2018-12-13 | C1 | 2128h |  | IMSProtoc16 | Leis, Peter, Nokia | Rel-16 | 82 |  | peter.leis@nokia.com |
| 413 | 205 | **410 - 430 MHz E-UTRA FDD Band(s) for LTE PPDR and PMR/PAMR in Europe** | 262d | 2018-12-13 | 2019-12-13 |  |  | 26090d |  | R4 | 6288h |  | LTE410_Europe_PPDR | Nokia | Rel-16 | 82 |  |  |
| 414 | 205.1 | Core part: 410 - 430 MHz E-UTRA FDD Band(s) for LTE PPDR and PMR/PAMR in Europe | 262d | 2018-12-13 | 2019-12-13 |  |  | 26090d | finish no earlier than 2019-12-13 | R4 | 2096h |  | LTE410_Europe_PPDR-Core | Nokia | Rel-16 | 82 |  |  |
| 415 | 205.2 | Perf. part: 410 - 430 MHz E-UTRA FDD Band(s) for LTE PPDR and PMR/PAMR in Europe | 262d | 2018-12-13 | 2019-12-13 |  |  | 26090d | finish no earlier than 2019-12-13 | R4 | 2096h |  | LTE410_Europe_PPDR-Perf | Nokia | Rel-16 | 82 |  |  |

Notes:
- 391: no Perf. part
- 392: no Perf. part
- 393: compare REL-14 WI LTE_eMob
- 394: compare REL-14 WI LTE_eMob
- 396: follow-up WI of REL-15 SI FS_LTE_arch_evo
- 397: follow-up WI of REL-15 SI FS_LTE_arch_evo; 27/6/18: Compl:0%->15%; 27/6/18: CD:Fri 15/06/18->Sun 15/12/19; 27/6/18: WID: RP-180531->RP-181375; 27/6/18: Release: Rel-15->Rel-16; 6/8/18: 37.470 to 473 and 36.470 to 473 added; / Impacted TSs and TRs: 37.470; 37.471; 37.472; 37.473; 36.470; 36.471; 36.472; 36.473
- 398: 14/3/19: 0%->50 / Impacted TSs and TRs: 32.251; 32.260; 32.298; 32.299
- 399: 30/6/17: 32.871 added;; 11/9/17: 0%->20; 15/12/17: 20%->30; 16/3/18: 30%->35; 7/6/18: 35%->100 / Impacted TSs and TRs: new; 32.871
- 400: 7/12/18: 0%->10 / Impacted TSs and TRs: New
- 401: 7/12/18: 0%->20; 14/3/19: 20%->30 / Impacted TSs and TRs: New
- 402: 7/12/18: 0%->50; 14/3/19: 50%->100 / Impacted TSs and TRs: 32.425; 28.621; 28.622; 28.623; 28.657; 28.658; 28.659
- 403: 7/12/18: 0%->60; 14/3/19: 60%->85 / Impacted TSs and TRs: New; 32.156
- 404: ; 14/3/19: 0%->40 / Impacted TSs and TRs: 32.240; 32.255; 32.290; 32.291; 32.298
- 405: ; 14/3/19: 0%->30 / Impacted TSs and TRs: 32.255; 32.291; 32.298
- 406: ; 14/3/19: 0%->10 / Impacted TSs and TRs: 28.540; 28.541; 28.622
- 407: ; 14/3/19: 0%->20 / Impacted TSs and TRs: 32.240; 32.254; 32.290; 32.291; 32.298
- 408: ; 14/3/19: 0%->20 / Impacted TSs and TRs: 32.240; 32.290; 32.291; 32.298; 32.297
- 409: ; 14/3/19: 0%->25 / Impacted TSs and TRs: 28.533; 28.532; 28.531
- 410: Impacted TSs and TRs: 32.421; 32.422; 28.530; 28.532; 28.533; 28.540; 28.541
- 411: Impacted TSs and TRs: 33.107; 33.108; 33.126; 33.127; 33.128
- 412: ; 14/3/19: 0%->25 / Impacted TSs and TRs: 23.218; 24.229; 24.930; 29.163; 29.165; 29.292

| ID | WBS | Task | Type | Duration | Start | Finish | Complete | Remaining | Total slack | Constraint | Resources | Work | Actual work | Acronym | WI rapporteur name | Release | TSG approved | PCG approved | Impacted TSs and TRs | WI rapporteur e-mail |
| --- | --- | --- | --- | --- | --- | --- | --- | --- | --- | --- | --- | --- | --- | --- | --- | --- | --- | --- | --- | --- |
| 416 | 206 | **High power UE (power class 2) for EN-DC (1 LTE TDD band + 1 NR TDD band)** |  | 262d | 2018-12-13 | 2019-12-13 |  |  | 26090d |  | R4 | 6288h |  | ENDC_UE_PC2_TDD_TDD | CMCC | Rel-16 | 82 |  |  |  |
| 417 | 206.1 | Core part: High power UE (power class 2) for EN-DC (1 LTE TDD band + 1 NR TDD band) |  | 262d | 2018-12-13 | 2019-12-13 |  |  | 26090d | start no earlier than 2018-12-13 | R4 | 2096h |  | ENDC_UE_PC2_TDD_TDD-Core | CMCC | Rel-16 | 82 |  |  |  |
| 418 | 206.2 | Perf. part: Power class 2 UE for EN-DC (1 LTE TDD band + 1 NR TDD band) |  | 262d | 2018-12-13 | 2019-12-13 |  |  | 26090d | start no earlier than 2018-12-13 | R4 | 2096h |  | ENDC_UE_PC2_TDD_TDD-Perf | CMCC | Rel-16 | 82 |  |  |  |
| 419 | 207 | LTE/NR spectrum sharing in Band 41/n41 frequency range |  | 134d | 2018-12-13 | 2019-06-18 |  |  | 26218d | start no earlier than 2018-12-13 | R4 | 1072h |  | NR_n41_LTE_41_coex-Core | KDDI | Rel-16 | 82 |  |  |  |
| 420 | 208 | **(Small) Technical Enhancements and Improvements for Rel-16** |  | 330d? | 2017-09-11 A | 2018-12-14 A | 100% |  |  |  |  |  |  | TEI16 |  | Rel-16 | 77 | 41 |  |  |
| 421 | 208.1 | (IETF) The Transport Layer Security (TLS) Protocol Version 1.3 (RFC 8446) | milestone | 0d? | 2017-09-11 A | 2018-12-14 A | 100% |  |  | finish no earlier than 2018-12-14 | S3-IETF |  |  | TEI16 |  | Rel-16 | 80 | 41 |  |  |
| 422 | 209 | Release 16 Studies with no corresponding Feature | milestone | 0d? | 2016-03-15 A | 2016-03-15 A | 100% |  |  | start no earlier than 2016-03-15 |  |  |  |  |  | Rel-16 |  |  |  |  |
| 423 | 210 | Release 16 Studies on 5G/5GS/5GC/NR | milestone | 0d? | 2016-06-09 A | 2016-06-09 A | 100% |  |  | finish no earlier than 2016-06-09 |  |  |  |  |  | Rel-16 |  |  |  |  |
| 424 | 211 | Study on system architecture for next generation real time communication services |  | 202d? | 2018-06-06 | 2019-03-14 |  |  | 26286d | finish no earlier than 2019-03-14 | S2 | 1616h |  | FS_NG_RTC | Yi Jiang | Rel-16 | 80 | 41 | New | jiangyi at chinamobile dot com |
| 425 | 212 | Study on Security Aspects of the 5G Service Based Architecture |  | 73d? | 2018-06-06 A | 2018-09-14 | 76% | 17.52d? | 26415d | finish no earlier than 2018-09-14 | S3 | 584h | 438h | FS_SBA_Sec | Hans Christian Rudolph, Deutsche Telekom AG | Rel-16 | 80 | 41 | New; 33.855 | hans-christian.rudolph@telekom.de |
| 426 | 213 | Study on Self-Organizing Networks (SON) for 5G |  | 202d? | 2018-09-06 A | 2019-06-14 | 40% | 121.2d? | 26220d | finish no earlier than 2019-06-14 | S5 | 1616h |  | FS_SON_5G | Joey Chou, Intel | Rel-16 | 81 | 41 | New | joey<dot>chou<at>intel<dot>com |
| 427 | 214 | Study on Load and Overload Control of 5GC Service Based Interfaces |  | 268d? | 2018-06-06 A | 2019-06-14 | 50% | 134d? | 26220d | finish no earlier than 2019-06-14 | C4 | 2144h | 107.2h | FS_LOLC | Sridhar Bhaskaran (Huawei) | Rel-16 | 80 | 41 | New; 22.943 | sridhar.bhaskaran@huawei.com |
| 428 | 215 | Study on security aspects of single radio voice continuity from 5G to UTRAN |  | 262d? | 2018-03-15 A | 2019-03-15 A | 100% |  |  | finish no earlier than 2019-03-15 | S3 | 2096h | 2096h | FS_5G_UTRAN_SEC | Feng Gao, China Unicom | Rel-16 | 79 | 40 | 33.856 | gaofeng149@chinaunicom.cn |
| 429 | 216 | Study on supporting 256-bit algorithms for 5G |  | 196d? | 2017-12-15 A | 2018-09-14 A | 100% |  |  | finish no earlier than 2018-09-14 | S3 | 1568h | 1568h | FS_256_Algo | Evans, Tim, Vodafone Group | Rel-16 | 78 | 40 | new | tim.evans1@vodafone.com |
| 430 | 217 | Study on IETF QUIC Transport for Service Based Interfaces |  | 266d? | 2018-06-06 A | 2019-06-12 | 75% | 66.5d? | 26222d | finish no earlier than 2019-06-12 | C4 | 2128h | 646.4h | FS_QUIC | Sridhar Bhaskaran (Huawei) | Rel-16 | 80 | 41 | New; 29.893 | sridhar.bhaskaran@huawei.com |
| 431 | 218 | Study on User Plane Protocol in 5GC |  | 391d? | 2017-12-15 A | 2019-06-14 | 70% | 117.3d? | 26220d | finish no earlier than 2019-06-14 | C4 | 3128h | 156.4h | FS_UPPS | Satoru Matsushima, SoftBank Corp | Rel-16 | 78 | 40 | 29.892 | satoru.matsushima@g.softbank.co.jp |
| 432 | 219 | Study on Application Awareness Interworking between LTE and NR |  | 261d? | 2018-03-15 A | 2019-03-14 | 30% | 182.7d? | 26286d | finish no earlier than 2019-03-14 | S2 | 2088h | 626.4h | FS_AAI_LTE_NR | Biao Long, China Telecom | Rel-16 | 79 | 40 | new; 23.727 | longb.gd@chinatelecom.cn |
| 433 | 220 | Study on NR beyond 52.6 GHz |  | 66d? | 2018-06-15 | 2018-09-14 |  |  | 26415d | finish no earlier than 2018-09-14 | RP | 528h |  | FS_NR_beyond_52GHz | Intel | Rel-16 | 80 | 41 | 38.8xx |  |
| 434 | 221 | Study on LTE-based 5G terrestrial broadcast |  | 196d? | 2018-06-15 | 2019-03-15 |  |  | 26285d | finish no earlier than 2019-03-15 | R1 | 1568h |  | FS_LTE_terr_bcast | Qualcomm | Rel-16 | 80 | 41 |  |  |
| 435 | 222 | Study on remote interference management for NR |  | 131d? | 2018-06-15 A | 2018-12-15 A | 100% |  |  | finish no earlier than 2018-12-15 | R1 | 1048h | 1048h | FS_NR_RIM | CMCC | Rel-16 | 80 | 41 |  |  |
| 436 | 223 | Study on RAN-centric data collection and utilization for LTE and NR |  | 261d? | 2018-06-01 | 2019-06-01 |  |  | 26230d | finish no earlier than 2019-06-01 | R3 | 2088h |  | FS_LTE_NR_data_collect | CMCC | Rel-16 | 80 | 41 |  |  |
| 437 | 224 | Study on radiated metrics and test methodology for the verification of multi-antenna reception performance of NR UEs |  | 391d? | 2018-06-15 | 2019-12-15 |  |  | 26090d | finish no earlier than 2019-12-15 | R4 | 3128h |  | FS_NR_MIMO_OTA_test | CATR | Rel-16 | 80 | 41 |  |  |
| 438 | 225 | Study on evaluation for 2 RX exception in Rel-15 vehicle mounted UE for NR |  | 141d? | 2018-06-01 A | 2018-12-15 A | 100% |  |  | finish no earlier than 2018-12-15 | R4 | 1128h | 1128h | FS_NR_2RX_vehUE | Samsung | Rel-16 | 80 | 41 |  |  |
| 439 | 226 | Study of test methods for New Radio |  | 393d? | 2017-03-15 A | 2018-09-14 A | 100% |  |  | finish no earlier than 2018-09-15 | R4 | 3144h | 3144h | FS_NR_test_methods | Intel | Rel-16 | 75 | 38 | 38.810 |  |
| 440 | 227 | Study on Non-Orthogonal Multiple Access (NOMA) for NR |  | 458d? | 2017-03-15 A | 2018-12-14 A | 100% |  |  | finish no earlier than 2018-12-15 | R1 | 3664h | 3664h | FS_NR_NOMA | ZTE | Rel-16 | 75 | 38 | 32.812 |  |
| 441 | 228 | Study on 5G security enhancement against false base stations |  | 137d? | 2018-09-06 A | 2019-03-15 | 10% | 123.3d? | 26285d | finish no earlier than 2019-03-15 | S3 | 1096h |  | FS_5GFBS | Ivy Guo, Apple | Rel-16 | 81 | 41 | New | ivy_guo@apple.com |
| 442 | 229 | Study of KDF negotiation for 5G System Security |  | 202d? | 2018-09-06 A | 2019-06-14 | 55% | 90.9d? | 26220d | finish no earlier than 2019-06-14 | S3 | 1616h |  | FS_5GS_KDF | Ahmad Muhanna | Rel-16 | 81 | 41 | New | ahmad.muhanna@huawei.com |
| 443 | 230 | Study on Long Term Key Update Procedures |  | 400d? | 2017-06-05 A | 2018-12-14 A | 100% |  |  | finish no earlier than 2018-12-14 | S3 | 3200h | 3200h | FS_LTKUP | Evans, Tim, Vodafone | Rel-16 | 76 | 39 | Internal TR | tim.evans1@vodafone.com |
| 444 | 231 | Study on Long Term Key Update Process (LTKUP) Detailed solutions | manual | 201d | 2018-12-06 | 2019-09-12 |  |  |  |  | S3 | 1608h |  | FS_LTKUP_Detail | Evans, Tim, Vodafone | Rel-16 | 82 |  |  | tim.evans1@vodafone.com |
| 445 | 232 | Study on User Plane Integrity Protection | manual | 201d | 2018-12-06 | 2019-09-12 |  |  |  |  | S3 | 1608h |  | FS_UP_IP_Sec | Evans, Tim, Vodafone | Rel-16 | 82 |  |  | tim.evans1@vodafone.com |
| 446 | 233 | Study on eXtended Reality (XR) in 5G |  | 314d? | 2018-10-02 A | 2019-12-13 | 35% | 204.1d? | 26090d | start no earlier than 2018-10-02 | S4 | 2512h |  | FS_5GXR | Thomas Stockhammer, Qualcomm Incorporated | Rel-16 | 81 | 41 | 26.9xx | tsto@qti.qualcomm.com |
| 447 | 234 | Study on 7 - 24 GHz frequency range for NR | manual | 262d | 2018-12-15 | 2019-12-15 |  |  |  |  | R4 | 2096h |  | FS_7to24GHz_NR | Huawei | Rel-16 | 82 |  |  |  |
| 448 | 235 | Study on authentication enhancements in 5GS | manual | 201d | 2018-12-06 | 2019-09-12 |  |  |  |  | S3 | 1608h |  | FS_AUTH_ENH | Ben Henda, Noamen, Ericsson | Rel-16 | 82 |  | new | noamen.ben.henda@ericsson.com. |
| 449 | 236 | Study on Ues Supporting Handset Mode with Non-Traditional Earpieces | manual | 130.88d | 2019-03-14 | 2019-09-12 |  |  |  |  | S4 | 1047h |  | FS_HaNTE | Schevciw, Andre, Qualcomm Incorporated | Rel-16 |  |  | New | aschevci@qti.qualcomm.com |
| 450 | 237 | Release 16 other Studies | milestone | 0d? | 2016-06-09 A | 2016-06-09 A | 100% |  |  | finish no earlier than 2016-06-09 |  |  |  |  |  | Rel-16 |  |  |  |  |
| 451 | 238 | Study on supporting Flexible Local Area Data Network |  | 202d? | 2018-06-06 | 2019-03-14 |  |  | 26286d | finish no earlier than 2019-03-14 | S2 | 1616h |  | FS_FLADN | LG Electronics, | Rel-16 | 80 | 41 | New | hyuns.kim@lge.com |
| 452 | 239 | Study on authentication and key management for applications based on 3GPP credential in 5G |  | 202d? | 2018-06-06 A | 2019-03-14 | 20% | 161.6d? | 26286d | finish no earlier than 2019-03-14 | S3 | 1616h | 80.8h | FS_AKMA | Jin Peng, China Mobile | Rel-16 | 80 | 41 | New; 33.835 | pengjin@chinamobile.com |
| 453 | 240 | Study on enhancements to IMS for new real time communication services |  | 71d? | 2017-09-08 A | 2017-12-15 A | 100% |  |  | start no earlier than 2017-09-08 | S1 | 568h | 568h | FS_enIMS | China Mobile, Hui Cai | Rel-16 | 77 | 39 | New; 22.823 | caihui at chinamobile dot com |
| 454 | 241 | Study on protocol enhancement for real time communication |  | 202d? | 2018-06-06 | 2019-03-14 |  |  | 26286d | finish no earlier than 2019-03-14 | S5 | 1616h |  | FS_PROTIMP | Olaf Pollakowski, Nokia | Rel-16 | 80 | 41 | New; 28.823 | olaf.pollakowski@nokia.com |
| 455 | 242 | Study on integration of ONAP and 3GPP configuration management services for 5G networks |  | 202d? | 2018-06-06 A | 2019-03-14 A | 100% |  |  | finish no earlier than 2019-03-14 | S5 | 1616h | 1616h | FS_ONAPCINT | Li Gang, Ericsson | Rel-16 | 80 | 41 | New | gang.g.li@ericsson.com |
| 456 | 243 | Study on integration of ONAP DCAE and 3GPP management architecture |  | 326d? | 2017-12-15 A | 2019-03-15 A | 100% |  |  | finish no earlier than 2019-03-15 | S5 | 2608h | 2608h | FS_ONAPDCAE | ORANGE (Jean-Michel Cornily | Rel-16 | 78 | 40 | 28.900 | jeanmichel.cornily@orange.com |
| 457 | 244 | Study on management aspects of edge computing |  | 202d? | 2018-06-06 A | 2019-03-14 | 50% | 101d? | 26286d | finish no earlier than 2019-03-14 | S5 | 1616h | 161.6h | FS_MAN_EC | Joey Chou, Intel | Rel-16 | 80 | 41 | New; 28.803 | joey<dot>chou<at>intel<dot>com |
| 458 | 245 | Study on encrypted traffic detection |  | 528d? | 2017-06-05 A | 2019-06-12 | 70% | 158.4d? | 26222d | finish no earlier than 2019-06-12 | S2 | 4224h | 1870.4h | FS_ENTRADE | Chi Ren, China Unicom | Rel-16 | 76 | 39 | new 23.787 | renchi1@chinaunicom.cn |
| 459 | 246 | Study on self-evaluation towards IMT-2020 submission |  | 653d? | 2016-12-14 A | 2019-06-14 | 35% | 424.45d? | 26220d | finish no earlier than 2019-06-15 | ITU-R AH | 5224h | 1828.4h | FS_5G_eval | Huawei | Rel-16 | 75 | 38 |  |  |
| 460 | 247 | Study on 6 GHz for LTE and NR |  | 261d? | 2017-12-15 A | 2018-12-14 | 30% | 182.7d? | 26350d | finish no earlier than 2018-12-15 | RP | 2088h | 626.4h | FS_6GHz_LTE_NR | Ericsson | Rel-16 | 78 | 40 | 37.890; 37.107 |  |
| 461 | 248 | Study on management aspects of communication services |  | 202d? | 2018-09-06 A | 2019-06-14 | 70% | 60.6d? | 26220d | finish no earlier than 2019-06-14 | S5 | 1616h |  | FS_CSMAN | Groenendijk, Jan, Ericsson | Rel-16 | 81 | 41 | New | jan<dot>Groenendijk<at>ericsson<dot>com. |
| 462 | 249 | Study on SECAM and SCAS for 3GPP virtualized network products |  | 249d? | 2018-10-02 A | 2019-09-13 | 5% | 236.55d? | 26155d | start no earlier than 2018-10-02 | S3 | 1992h |  | FS_VNP_SECAM_SCAS | Minpeng Qi, China Mobile | Rel-16 | 81 | 41 | New | qiminpeng@chinamobile.com |
| 463 | 250 | Study on Security Impacts of Virtualisation | manual | 201d | 2018-12-06 | 2019-09-12 |  |  |  |  | S3 | 1608h |  | FS_SIV | Alex Leadbeater, BT Plc | Rel-16 | 82 |  |  | alex.leadbeater@bt.com |
| 464 | 251 | Study on Typical Traffic Characteristics of Media Services |  | 314d? | 2018-10-02 A | 2019-12-13 | 45% | 172.7d? | 26090d | start no earlier than 2018-10-02 | S4 | 2512h |  | FS_TyTrac | Thomas Stockhammer, Qualcomm Incorporated | Rel-16 | 81 | 41 | 26.9xx | tsto@qti.qualcomm.com |
| 465 | 252 | Study on non-file-based trace reporting |  | 135d? | 2018-12-06 | 2019-06-12 |  |  | 26222d | finish no earlier than 2019-06-12 | S5 | 1080h |  | FS_OAM_RTT | Andrianov, Anatoly, Nokia | Rel-16 | 82 |  |  | anatoly.andrianov@nokia.com |
| 466 | 253 | Study on ambient noise test methodology for evaluation of acoustic UE performance | manual | 266d | 2018-12-06 | 2019-12-12 |  |  |  |  | S4 | 2128h |  | FS_ANTeM | Jan Reimes, HEAD acoustics GmbH | Rel-16 | 82 |  |  | jan.reimes@head-acoustics.de |
| 467 | 254 | Study on high power UE (power class 2) for EN-DC (1 LTE FDD band + 1 NR TDD band) |  | 134d | 2018-12-13 | 2019-06-18 |  |  | 26218d | start no earlier than 2018-12-13 | R4 | 1072h |  | FS_ENDC_UE_PC2_FDD_TDD | China Unicom | Rel-16 | 82 |  |  |  |
| 468 | 255 | Release 15 Features | milestone | 0d? | 2016-03-15 A | 2016-03-15 A | 100% |  |  | finish no earlier than 2016-03-15 |  |  |  |  |  | Rel-15 |  |  |  |  |
| 469 | 256 | Release 15 Features on 5G | milestone | 0d? | 2016-06-09 A | 2016-06-09 A | 100% |  |  | finish no earlier than 2016-06-09 |  |  |  |  |  | Rel-15 |  |  |  |  |

Notes:
- 419: no Perf. part; changes will happen only on NR side
- 422: -
- 423: -
- 425: 6/8/18: 33.855 added;; 10/9/18: 65%->75; 7/12/18: 75%->76
- 426: 7/12/18: 0%->10; 14/3/19: 10%->40
- 427: 6/8/18: 22.943 added;; 10/9/18: 0%->5; 10/12/18: 5%->25; 14/3/19: 25%->50
- 428: 27/3/18: 33.856 added;; 7/6/18: 0%->50; 10/9/18: 50%->79; 7/12/18: 79%->100
- 429: 16/3/18: 0%->30; 7/6/18: 30%->55; 10/9/18: 55%->60; 7/12/18: 60%->100
- 430: 6/8/18: 29.893 added;; 10/9/18: 0%->40; 10/12/18: FCD:03/19->06/19; 10/12/18: 40%->50; 10/12/18: WID:CP-181194->CP-183245; 14/3/19: 50%->75
- 431: 16/3/18: 0%->5; 2/10/18: WID:CP-173160->CP-182052; 2/10/18: FCD:09/18->06/19; 14/3/19: 20%->70
- 432: 7/6/18: 0%->30; 6/8/18: 23.727 added;
- 434: TR 36.7xx
- 435: TR 38.8xx; see follow-up REL-16 WI NR_CLI_RIM; 16/1/19: 0%->100
- 436: TR 37.8XX, related to SON, MDT
- 437: related REL-15 SI FS_NR_test_methods
- 438: TR 38.8XX; 16/1/19: 0%->100
- 439: TR 38.8XX; 19/6/17: Compl:0%->10%; 19/6/17: WID: RP-170824->RP-171021; 30/6/17: 38.810 added;19/9/17: Compl:10%->15%19/9/17: WID: RP-171021->RP-171828; 8/1/18: Compl:15%->20%27/3/18: Compl:20%->45%27/3/18: CD:Thu 15/ ; 2; 16/1/19: 75%->100
- 440: TR 38.8XX; 19/6/17: WID: RP-170829->RP-171043; 30/6/17: 32.812 added;; 27/6/18: Compl:0%->40%; 27/6/18: CD:Fri 15/06/18->Sat 15/12/18; 27/6/18: WID: RP-171043->RP-181403;; 16/1/19: 40%->100
- 441: 7/12/18: 0%->10
- 442: 7/12/18: 0%->55
- 443: 11/9/17: 0%->10; 15/12/17: 10%->70; 15/12/17: FCD:12/17->03/18; 16/3/18: 70%->90; 16/3/18: FCD:03/18->06/18; 7/6/18: FCD:06/18->12/18. 10/9/18: moved from Rel-15 as per SP-180687; 7/12/18: 90%->100
- 446: 2/10/18: Moved from Rel-17. 17/01/19: acronym corrected from FS_XR5G; 12/3/19: 0%->35
- 447: TR. 38.8xx
- 448: 07/19: Rel corrected, was wrongly allocated to Rel-17
- 450: -
- 451: 10/9/18: FCD:12/18->03/19
- 452: 6/8/18: 33.835 added;; 7/12/18: 5%->20
- 453: 11/9/17: 0%->20; 15/12/17: 22.823 added;; 15/12/17: 20%->75; 16/3/18: 75%->100
- 454: 6/8/18: 28.823 added;
- 455: 10/9/18: 0%->5; 7/12/18: 5%->60; 14/12/18: WID:SP-180388->SP-181075; 14/3/19: 60%->100
- 456: 16/3/18: 0%->10; 27/3/18: 28.900 added;; 7/6/18: 10%->20; 7/6/18: FCD:09/18->03/19; 15/6/18: WID:SP-170948->SP-180389; 10/9/18: 20%->35; 7/12/18: 35%->80; 14/12/18: WID:SP-180389->SP-181074; 14/3/19: 80%->100
- 457: 6/8/18: 28.803 added;; 10/9/18: 0%->10; 7/12/18: 10%->20; 14/3/19: 20%->50
- 458: ; 15/12/17: Changed Rel-15->Rel-16; 16/3/18: WID:SP-170381->SP-170934; 16/3/18: 0%->20; 7/6/18: 20%->70; 14/12/18: FCD:09/18->06/19. Name changed
- 459: TR 38.9XX; 19/6/17: CD:Sat 15/09/18->Fri 15/06/18; 19/6/17: WID: RP-170832->RP-171451; 19/6/17: Release: Rel-16->Rel-15; 8/1/18: Compl:0%->15%27/3/18: Compl:15%->25%; 27/6/18: Compl:25%->35%; 27/6/18: CD:Fri 15/0
- 460: SI under RAN leadership; TR 37.8XX27/3/18: Compl:0%->25%27/3/18: WID: RP-172804->RP-180168; 27/3/18: 37.890 added;; 27/3/18: 37.107 added;; 27/6/18: Compl:25%->30%; 27/6/18: CD:Fri 15
- 461: 7/12/18: 0%->40; 14/3/19: 40%->70
- 462: 2/10/18: Moved from Rel-17; 7/12/18: 0%->5
- 464: 2/10/18: Moved from Rel-17; 12/3/19: 0%->45
- 466: 12/3/19: 0%->10
- 467: EN-DC = E-UTRA-NR Dual Connectivity; TR 37.8xx
- 468: -
- 469: -

| ID | WBS | Task | Duration | Start | Finish | Complete | Remaining | Total slack | Constraint | Resources | Work | Actual work | Acronym | PCG approved | WI rapporteur name | WI rapporteur e-mail | Release | TSG approved |
| --- | --- | --- | --- | --- | --- | --- | --- | --- | --- | --- | --- | --- | --- | --- | --- | --- | --- | --- |
| 470 | 257 | **5G System - Phase 1** | 788d? | 2016-06-09 A | 2019-06-14 | 92% | 61.71d? | 26220d |  |  | 51296h | 44985.8h | 5GS_Ph1 | 38 | China Mobile, Tao Sun | suntao@chinamobile.com | Rel-15 | 74 |
| 471 | 257.1 | Study on Charging Aspects of 5G System Architecture Phase 1 | 206d? | 2017-03-03 A | 2017-12-15 A | 100% |  |  | finish no earlier than 2017-12-15 | S5 | 1648h | 1648h | FS_5GS_Ph1_CH | 38 | Chen, Shan, Huawei | chenshan@huawei.com | Rel-15 | 75 |
| 472 | 257.2 | (Stage 1 of 5G) New Services and Markets Technology Enablers | 201d? | 2016-06-09 A | 2017-03-15 A | 100% |  |  | finish no earlier than 2017-03-15 | S1 | 1608h | 1608h | SMARTER | 37 | Li, Alice | alice.li@vodafone.com | Rel-15 | 72 |
| 473 | 257.3 | Stage 2 of 5G System - Phase 1 | 271d? | 2016-12-01 A | 2017-12-14 A | 100% |  |  | finish no earlier than 2017-12-14 | S2 | 2168h | 2168h | 5GS_Ph1 | 38 | China Mobile, Tao Sun | suntao@chinamobile.com | Rel-15 | 74 |
| 474 | 257.4 | Security aspects of 5G System - Phase 1 | 337d? | 2017-03-02 A | 2018-06-15 A | 100% |  |  | finish no earlier than 2018-06-15 | S3 | 2696h | 2696h | 5GS_Ph1-SEC | 38 | NTT DOCOMO, Alf Zugenmaier | alf.zugenmaier@hm.edu | Rel-15 | 75 |
| 475 | 257.5 | **CT aspects of 5G System - Phase 1** | 335d? | 2017-03-03 A | 2018-06-14 | 99% | 0d? | 0d |  | ct | 28960h | 26353.8h | 5GS_Ph1-CT | 38 | Song Yue (China Mobile) | songyue at chinamobile.com | Rel-15 | 75 |
| 476 | 257.5.1 | **Studies on CT1 aspects of 5G System - Phase 1** | 205d? | 2017-03-03 A | 2017-12-14 A | 100% |  |  |  |  | 11480h | 11480h | 5GS_Ph1-CT | 38 | Herrero Veron, Christian (Huawei) | Christian.Herrero at huawei.com | Rel-15 | 75 |
| 477 | 257.5.1.1 | Study on 5G Network selection | 205d? | 2017-03-03 A | 2017-12-14 A | 100% |  |  | finish no earlier than 2017-12-14 | C1 | 1640h | 1640h | 5GS_Ph1-CT | 39 | Herrero Veron, Christian (Huawei) | Christian.Herrero at huawei.com | Rel-15 | 77 |
| 478 | 257.5.1.2 | Study on 5G Mobility management | 205d? | 2017-03-03 A | 2017-12-14 A | 100% |  |  | finish no earlier than 2017-12-14 | C1 | 1640h | 1640h | 5GS_Ph1-CT | 39 | Herrero Veron, Christian (Huawei) | Christian.Herrero at huawei.com | Rel-15 | 77 |
| 479 | 257.5.1.3 | Study on 5G Session management | 205d? | 2017-03-03 A | 2017-12-14 A | 100% |  |  | finish no earlier than 2017-12-14 | C1 | 1640h | 1640h | 5GS_Ph1-CT | 39 | Herrero Veron, Christian (Huawei) | Christian.Herrero at huawei.com | Rel-15 | 77 |
| 480 | 257.5.1.4 | Study on 5G Non-3GPP access networks | 205d? | 2017-03-03 A | 2017-12-14 A | 100% |  |  | finish no earlier than 2017-12-14 | C1 | 1640h | 1640h | 5GS_Ph1-CT | 39 | Herrero Veron, Christian (Huawei) | Christian.Herrero at huawei.com | Rel-15 | 77 |
| 481 | 257.5.1.5 | Study on 5G Interworking with EPC | 205d? | 2017-03-03 A | 2017-12-14 A | 100% |  |  | finish no earlier than 2017-12-14 | C1 | 1640h | 1640h | 5GS_Ph1-CT | 39 | Herrero Veron, Christian (Huawei) | Christian.Herrero at huawei.com | Rel-15 | 77 |
| 482 | 257.5.1.6 | Study on 5G System core network impact on services, network functions and capabilities | 205d? | 2017-03-03 A | 2017-12-14 A | 100% |  |  | finish no earlier than 2017-12-14 | C1 | 1640h | 1640h | 5GS_Ph1-CT | 39 | Herrero Veron, Christian (Huawei) | Christian.Herrero at huawei.com | Rel-15 | 77 |
| 483 | 257.5.1.7 | Study on 5G Network slicing | 205d? | 2017-03-03 A | 2017-12-14 A | 100% |  |  | finish no earlier than 2017-12-14 | C1 | 1640h | 1640h | 5GS_Ph1-CT | 39 | Herrero Veron, Christian (Huawei) | Christian.Herrero at huawei.com | Rel-15 | 77 |
| 484 | 257.5.2 | **CT1 aspects of 5G System - Phase 1 (normative work)** | 130d? | 2017-12-15 A | 2018-06-14 A | 100% |  |  |  | C1 | 8320h | 8320h | 5GS_Ph1-CT | 38 | Herrero Veron, Christian (Huawei) | Christian.Herrero at huawei.com | Rel-15 | 75 |
| 485 | 257.5.2.1 | 5G Network selection | 130d? | 2017-12-15 A | 2018-06-14 A | 100% |  |  | finish no earlier than 2018-06-14 | C1 | 1040h | 1040h | 5GS_Ph1-CT | 39 | Herrero Veron, Christian (Huawei) | Christian.Herrero at huawei.com | Rel-15 | 77 |
| 486 | 257.5.2.2 | 5G Mobility management | 130d? | 2017-12-15 A | 2018-06-14 A | 100% |  |  | start no earlier than 2017-12-15 | C1 | 1040h | 1040h | 5GS_Ph1-CT | 39 | Herrero Veron, Christian (Huawei) | Christian.Herrero at huawei.com | Rel-15 | 77 |
| 487 | 257.5.2.3 | 5G Session management | 130d? | 2017-12-15 A | 2018-06-14 A | 100% |  |  | start no earlier than 2017-12-15 | C1 | 1040h | 1040h | 5GS_Ph1-CT | 39 | Herrero Veron, Christian (Huawei) | Christian.Herrero at huawei.com | Rel-15 | 77 |
| 488 | 257.5.2.4 | 5G Non-3GPP access networks | 130d? | 2017-12-15 A | 2018-06-14 A | 100% |  |  | start no earlier than 2017-12-15 | C1 | 1040h | 1040h | 5GS_Ph1-CT | 39 | Herrero Veron, Christian (Huawei) | Christian.Herrero at huawei.com | Rel-15 | 77 |
| 489 | 257.5.2.5 | 5G Interworking with EPC | 130d? | 2017-12-15 A | 2018-06-14 A | 100% |  |  | start no earlier than 2017-12-15 | C1 | 1040h | 1040h | 5GS_Ph1-CT | 39 | Herrero Veron, Christian (Huawei) | Christian.Herrero at huawei.com | Rel-15 | 77 |
| 490 | 257.5.2.6 | 5G System core network impact on services, network functions and capabilities | 130d? | 2017-12-15 A | 2018-06-14 A | 100% |  |  | start no earlier than 2017-12-15 | C1 | 1040h | 1040h | 5GS_Ph1-CT | 39 | Herrero Veron, Christian (Huawei) | Christian.Herrero at huawei.com | Rel-15 | 77 |
| 491 | 257.5.2.7 | 5G Network slicing | 130d? | 2017-12-15 A | 2018-06-14 A | 100% |  |  | start no earlier than 2017-12-15 | C1 | 1040h | 1040h | 5GS_Ph1-CT | 39 | Herrero Veron, Christian (Huawei) | Christian.Herrero at huawei.com | Rel-15 | 77 |
| 492 | 257.5.3 | Study on CT3 aspects of 5G System - Phase 1 | 205d? | 2017-03-03 A | 2017-12-14 A | 100% |  |  | finish no earlier than 2017-12-14 | C3 | 1640h | 1640h | 5GS_Ph1-CT | 38 | Fernandez, Susana (Ericsson) | Susana.Fernandez at ericsson.com | Rel-15 | 75 |
| 493 | 257.5.4 | CT3 aspects of 5G System - Phase 1 | 130d? | 2017-12-15 A | 2018-06-14 A | 100% |  |  | start no earlier than 2017-12-15 | C3 | 1040h | 1040h | 5GS_Ph1-CT | 38 | Fernandez, Susana (Ericsson) | Susana.Fernandez at ericsson.com | Rel-15 | 75 |
| 494 | 257.5.5 | CT4 aspects of 5G System - Phase 1 | 205d? | 2017-03-03 A | 2017-12-14 A | 100% |  |  | finish no earlier than 2017-12-14 | C4 | 1640h | 1640h | 5GS_Ph1-CT | 38 | Landais, Bruno (Nokia) | Bruno.Landais at nokia.com | Rel-15 | 75 |
| 495 | 257.5.6 | Study on CT6 aspects of 5G System - Phase 1 | 205d? | 2017-03-03 A | 2017-12-14 A | 100% |  |  | finish no earlier than 2017-12-14 | C6 | 1640h | 1640h | 5GS_Ph1-CT | 38 | Amandeep Virk from Qualcomm |  | Rel-15 | 75 |
| 496 | 257.5.7 | CT6 aspects of 5G System - Phase 1 | 65d? | 2018-03-16 A | 2018-06-14 A | 100% |  |  | finish no earlier than 2018-06-14 | C6 | 520h | 520h | 5GS_Ph1-CT | 38 | Landais, Bruno (Nokia) | Bruno.Landais at nokia.com | Rel-15 | 75 |
| 497 | 257.6 | UE Conformance Test Aspects – 5G System Non-3GPP Access | 196d? | 2018-06-15 | 2019-03-15 |  |  | 26285d | finish no earlier than 2019-03-15 | R5 | 1568h |  | 5GS_Ph1-CT_n3GPPA-UEConTest |  | Motorola |  | Rel-15 | 80 |

Notes:
- 470: 15/12/17: 23.503 added;
- 471: 7/6/17: 0%->15; 11/9/17: 15%->60; 11/9/17: WID:SP-170128->SP-170659; 15/12/17: 60%->100; 21/12/17: WID:SP-170659->SP-170953
- 472: Resulting from FS_SMARTER; 19/9/16: 0%->55; 6/10/16: 22.261 added; 1/12/16: FCD:09/16->03/20; 1/12/16: 55%->75; 2/3/17: 75%->90; 7/6/17: 90%->100 / Impacted TSs and TRs: 22.261
- 473: 3/3/17: 0%->30; 7/6/17: 30%->55; 11/9/17: 55%->75; 21/12/17: 75%->95; 11/6/18: 95%->100 / Impacted TSs and TRs: 23.401, 23.167, 23.271, 23.002; 23.228, 23.401, 23.167, 23.271, 23.502, 23.501; 23.503
- 474: 7/6/17: 0%->10; 11/9/17: 10%->30; 15/12/17: 30%->65; 21/12/17: WID:SP-170234->SP-170881; 16/3/18: 65%->85; 16/3/18: FCD:03/18->06/18; 7/6/18: 85%->95; 10/9/18: WID:SP-170881->100; 10/9/18: 95%->100; 2/10/18: WID:SP-170881->SP-180693 / Impacted TSs and TRs: 33.501; 33.401; 33.210; 33.310; 33.220
- 475: 6/17: WID:CP-170204->CP-171105; 9/17: WID:CP-171105->CP-172034. Rapp changed, impacted TS clarified; 12/17: added: 24.501 ; 24.502 ; 29.520 added; 29.514; 29.513 ; 29.520a; 29.514a; 12/17: 29.519 added; 29.516 added;; : 2.. 3/18: 29.554 added;29.59; 6/...; 10/12/18: WID:CP-182226->CP-183243 / Impacted TSs and TRs: 24.501; 24.502; 29.520; 29.514; 29.513; ; 29.520a; 29.514a; 29.519; 29.516; 29.512; 29.508; 29.507; 29.551; 29.554; 29.522; 24.568; 29.521; 29.525; 29.524; 29.523
- 476: 18/12/17: WID:CP-172034->CP-173161 / Impacted TSs and TRs: 23.122; 23.040; 23.041; 24.007; 24.301; 24.008; 24.302; 24.011; 24.312; 24.305; 24.368; 27.007
- 477: Task introduced as per CT1's chair e-mail; 11/9/17: 10%->55; 15/12/17: 55%->80; 16/3/18: 80%->100
- 478: Task introduced as per CT1's chair e-mail; 11/9/17: 40%->70; 15/12/17: 70%->100
- 479: Task introduced as per CT1's chair e-mail; 11/9/17: 35%->75; 15/12/17: 75%->100
- 480: Task introduced as per CT1's chair e-mail; 11/9/17: 15%->55; 15/12/17: 55%->100
- 481: Task introduced as per CT1's chair e-mail; 11/9/17: 15%->45; 15/12/17: 45%->100
- 482: Task introduced as per CT1's chair e-mail; 11/9/17: 20%->65; 15/12/17: 65%->85; 16/3/18: 85%->100
- 483: Task introduced as per CT1's chair e-mail; 11/9/17: 10%->45; 15/12/17: 45%->100
- 484: Impacted TSs and TRs: 23.122; 23.040; 23.041; 24.007; 24.301; 24.008; 24.302; 24.011; 24.312; 24.305; 24.368; 27.007
- 485: 16/3/18: 0%->60; 7/6/18: 60%->100
- 486: 15/12/17: 0%->25; 16/3/18: 25%->70; 7/6/18: 70%->95; 10/9/18: 95%->100
- 487: 15/12/17: 0%->35; 16/3/18: 35%->85; 7/6/18: 85%->100
- 488: 15/12/17: 0%->20; 16/3/18: 20%->60; 7/6/18: 60%->95; 10/9/18: 95%->100
- 489: 15/12/17: 0%->20; 16/3/18: 20%->60; 7/6/18: 60%->100
- 490: 15/12/17: 0%->10; 16/3/18: 10%->70; 7/6/18: 70%->90; 10/9/18: 90%->100
- 491: 15/12/17: 0%->10; 16/3/18: 10%->60; 7/6/18: 60%->100
- 492: 5/6/17: 0%->20; 15/12/17: 20%->95; 22/3/18: 95%->100 / Impacted TSs and TRs: 29.213; 29.214; 29.219; 29.122
- 493: 5/6/17: 0%->20; 15/12/17: 20%->95; 7/6/18: 35%->70; 7/6/18: 70%->100 / Impacted TSs and TRs: 29.213; 29.214; 29.219; 29.122
- 494: 5/6/17: 0%->5; 11/9/17: 5%->25; 15/12/17: 25%->45; 16/3/18: 45%->50; 7/6/18: 50%->95; 10/9/18: 95%->99; 10/12/18: 99%->100 / Impacted TSs and TRs: 23.003; 23.008; 23.380; 29.281; 29.272; 29.274; 29.303
- 495: 5/6/17: 0%->10; 11/9/17: 10%->60; 15/12/17: 60%->85; 22/3/18: 85%->95; 7/6/18: 95%->100
- 496: 5/6/17: 0%->5; 11/9/17: 5%->25; 15/12/17: 25%->45; 16/3/18: 45%->50; 16/3/18: 0%->20; 7/6/18: 20%->90; 10/9/18: 90%->95. 10/9/18: 95->100 as per CT81 discussions; 10/12/18: 100%->95; 11/12/18: 95%->100 / Impacted TSs and TRs: 23.003; 23.008; 23.380; 29.281; 29.272; 29.274; 29.303
- 497: tested: non-3GPP Access part of REL-15 WI 5GS_Ph1-CT (note: 3GPP Access part of 5GS_Ph1-CT is already covered in REL-15 WI 5GS_NR_LTE-UEConTest);

| ID | WBS | Task | Type | Duration | Start | Finish | Complete | Remaining | Total slack | Constraint | Resources | Work | Actual work | Acronym | PCG approved | WI rapporteur name | WI rapporteur e-mail | Release | TSG approved | Status Report |
| --- | --- | --- | --- | --- | --- | --- | --- | --- | --- | --- | --- | --- | --- | --- | --- | --- | --- | --- | --- | --- |
| 498 | 257.7 | **IMS impact due to 5GS IP-CAN** |  | 205d? | 2017-09-04 A | 2018-06-15 A | 100% |  |  |  | ct | 6560h | 6560h | 5GS_Ph1-IMSo5G | 39 | Song Yue (China Mobile) | songyue (at) chinamobile (dot) com | Rel-15 | 76 |  |
| 499 | 257.7.1 | CT1 aspects of IMSo5G |  | 205d? | 2017-09-04 A | 2018-06-15 A | 100% |  |  | finish no earlier than 2018-06-15 | C1 | 1640h | 1640h | 5GS_Ph1-IMSo5G | 39 | Song Yue, China Mobile | songyue@chinamobile.com | Rel-15 | 77 |  |
| 500 | 257.7.2 | CT3 aspects of IMSo5G |  | 205d? | 2017-09-04 A | 2018-06-15 A | 100% |  |  | finish no earlier than 2018-06-15 | C3 | 1640h | 1640h | 5GS_Ph1-IMSo5G | 39 | Herrero Veron, Christian (Huawei) | Christian.Herrero at huawei.com | Rel-15 | 77 |  |
| 501 | 257.7.3 | CT4 aspects of IMSo5G |  | 205d? | 2017-09-04 A | 2018-06-15 A | 100% |  |  | finish no earlier than 2018-06-15 | C4 | 1640h | 1640h | 5GS_Ph1-IMSo5G | 39 | Herrero Veron, Christian (Huawei) | Christian.Herrero at huawei.com | Rel-15 | 77 |  |
| 502 | 257.8 | Service Based Interface for 5G Charging |  | 196d? | 2017-12-15 A | 2018-09-14 A | 100% |  |  | finish no earlier than 2018-09-14 | S5 | 1568h | 1568h | 5GS_Ph1-SBI_CH | 40 | Chen, Shan, Huawei | chenshan@huawei.com | Rel-15 | 78 |  |
| 503 | 257.9 | Data Charging in 5G System Architecture Phase 1 |  | 196d? | 2017-12-15 A | 2018-09-14 A | 100% |  |  | finish no earlier than 2018-09-14 | S5 | 1568h | 1568h | 5GS_Ph1-DCH | 40 | Gardella, Maryse, Nokia | maryse.gardella@nokia.com | Rel-15 | 78 |  |
| 504 | 257.10 | SMS Charging in 5G System Architecture Phase 1 |  | 72d? | 2018-09-06 A | 2018-12-14 A | 100% |  |  | finish no earlier than 2018-12-14 | S5 | 576h | 576h | 5GS_Ph1-SMSCH |  | Gardella, Maryse, Nokia | maryse.gardella@nokia.com | Rel-15 | 81 |  |
| 505 | 257.11 | Charging for IMS over 5G System Architecture Phase 1 |  | 30d? | 2018-05-07 A | 2018-06-15 A | 100% |  |  | start no earlier than 2018-05-07 | S5 | 240h | 240h | 5GS_Ph1_IMSCH |  | Gardella, Maryse, Nokia | maryse.gardella@nokia.com | Rel-15 | 80 |  |
| 506 | 257.12 | UE Conformance Test Aspects - CT6 aspects of 5G System |  | 267d? | 2018-06-07 A | 2019-06-14 | 5% | 253.65d? | 26220d | finish no earlier than 2019-06-14 | C6 | 2136h |  | 5GS_Ph1_UEConTest |  | Azem, Dania (COMPRION GmbH) | DAzem@comprion.com | Rel-15 | 80 |  |
| 507 | 258 | **EPC enhancements to support 5G New Radio via Dual Connectivity** |  | 271d? | 2017-03-02 A | 2018-03-15 A | 100% |  |  |  |  | 8336h | 8336h | EDCE5 | 38 | Chris Pudney, Vodafone Group | Chris Pudney, Vodafone Group | Rel-15 | 75 |  |
| 508 | 258.1 | SA2 aspects of EDCE5 |  | 141d? | 2017-03-02 A | 2017-09-14 A | 100% |  |  | finish no earlier than 2017-09-14 | S2 | 1128h | 1128h | EDCE5 | 38 | Chris Pudney, Vodafone Group |  | Rel-15 | 75 |  |
| 509 | 258.2 | SA3 aspects of EDCE5 |  | 141d? | 2017-03-02 A | 2017-09-14 A | 100% |  |  | finish no earlier than 2017-09-14 | S3 | 1128h | 1128h | EDCE5 | 38 | Adrian Escott, Qualcomm Incorporated |  | Rel-15 | 75 |  |
| 510 | 258.3 | **CT aspects of EDCE5** |  | 139d? | 2017-06-05 A | 2017-12-14 A | 100% |  |  |  | ct | 4448h | 4448h | EDCE5-CT | 39 | Jesús de Gregorio, Ericsson | jesus.de.gregorio@ericsson.com | Rel-15 | 76 |  |
| 511 | 258.3.1 | CT1 aspects of EDCE5 |  | 139d? | 2017-06-05 A | 2017-12-14 A | 100% |  |  | finish no earlier than 2017-12-14 | C1 | 1112h | 1112h | EDCE5-CT | 39 | Jesús de Gregorio, Ericsson | jesus.de.gregorio@ericsson.com | Rel-15 | 76 |  |
| 512 | 258.3.2 | CT3 aspects of EDCE5 |  | 139d? | 2017-06-05 A | 2017-12-14 A | 100% |  |  | finish no earlier than 2017-12-14 | C3 | 1112h | 1112h | EDCE5-CT | 39 | Jesús de Gregorio, Ericsson | jesus.de.gregorio@ericsson.com | Rel-15 | 76 |  |
| 513 | 258.3.3 | CT4 aspects of EDCE5 |  | 139d? | 2017-06-05 A | 2017-12-14 A | 100% |  |  | finish no earlier than 2017-12-14 | C4 | 1112h | 1112h | EDCE5-CT | 39 | Jesús de Gregorio, Ericsson | jesus.de.gregorio@ericsson.com | Rel-15 | 76 |  |
| 514 | 258.4 | Charging aspects of EDCE5: PS Charging enhancements to support 5G New Radio via Dual Connectivity |  | 204d? | 2017-06-05 A | 2018-03-15 A | 100% |  |  | finish no earlier than 2018-03-15 | S5 | 1632h | 1632h | EDCE5-CH | 39 | Törnkvist, Robert, Ericsson | robert.tornkvist(at)ericsson.com | Rel-15 | 76 |  |
| 515 | 259 | **New Radio Access Technology** |  | 588d? | 2017-03-15 A | 2019-06-14 | 52% | 285.03d? | 26220d |  | R1 | 13072h | 6363.52h | NR_newRAT | 38 | NTT DOCOMO |  | Rel-15 | 75 |  |
| 516 | 259.1 | Core part: New Radio Access Technology |  | 458d? | 2017-03-15 A | 2018-12-14 | 92% | 36.64d? | 26350d | finish no earlier than 2018-12-15 | R1 | 3664h | 3370.88h | NR_newRAT-Core | 38 | NTT DOCOMO |  | Rel-15 | 75 | RP-181466 |
| 517 | 259.2 | Perf. part: New Radio Access Technology |  | 588d? | 2017-03-15 A | 2019-06-14 | 20% | 470.4d? | 26220d | finish no earlier than 2019-06-15 | R4 | 4704h | 940.8h | NR_newRAT-Perf | 38 | NTT DOCOMO |  | Rel-15 | 75 |  |
| 518 | 260 | **LTE connectivity to 5G-CN** |  | 462d? | 2017-03-15 A | 2018-12-20 | 99% | 0d? | 0d |  | R2 | 9432h | 9416.33h | LTE_5GCN_connect | 38 | Huawei |  | Rel-15 | 75 |  |
| 519 | 260.1 | Core part: LTE connectivity to 5G-CN |  | 393d? | 2017-03-15 A | 2018-09-14 A | 100% |  |  | finish no earlier than 2018-09-15 | R2 | 3144h | 3144h | LTE_5GCN_connect-Core | 38 | Huawei |  | Rel-15 | 75 | RP-180862 |
| 520 | 260.2 | Perf. part: LTE connectivity to 5G-CN |  | 393d? | 2017-06-20 A | 2018-12-20 A | 100% |  |  | finish no earlier than 2018-12-20 | R4 | 3144h | 3144h | LTE_5GCN_connect-Perf | 38 | Huawei |  | Rel-15 | 75 | RP-180862 |
| 521 | 261 | UE Conformance Test Aspects - 5G system with NR and LTE |  | 392d? | 2017-06-15 A | 2018-12-14 | 15% | 333.2d? | 26350d | finish no earlier than 2018-12-15 | R5 | 3136h | 470.4h | 5GS_NR_LTE-UEConTest | 39 | Ericsson |  | Rel-15 | 76 |  |
| 522 | 262 | Release 15 Features on V2X | milestone | 0d? | 2016-06-09 A | 2016-06-09 A | 100% |  |  | finish no earlier than 2016-06-09 |  |  |  |  |  |  |  | Rel-15 |  |  |

Notes:
- 498: 8/9/17: WID:CP-171103->CP-172033; FCD: 12/17->06/18; 19/3/18: WID:CP-172033->CP-180094
- 499: 14/9/17: 0%->10; 15/12/17: 10%->65; rapporteur changed; 20/3/18: 65%->75; 7/6/18: 75%->95; 10/9/18: 95%->100 / Impacted TSs and TRs: 24.229; 24.167
- 500: 7/6/18: 0%->80; 10/9/18: 80%->100 / Impacted TSs and TRs: 29.213; 29.214
- 501: 7/6/18: 0%->100 / Impacted TSs and TRs: 23.008; 29.228; 29.229; 29.328; 29.329; 23.003
- 502: 16/3/18: 0%->15; 7/6/18: 15%->55; 7/6/18: FCD:06/18->09/18; 10/9/18: 55%->100 / Impacted TSs and TRs: TS 32.240; TS 32.298
- 503: 16/3/18: 0%->10; 7/6/18: 10%->60; 7/6/18: FCD:06/18->09/18; 10/9/18: 60%->100 / Impacted TSs and TRs: TS 32.240
- 504: 7/12/18: 0%->100 / Impacted TSs and TRs: 32.240; 32.274; 32.290; 32.291; 32.299; 32.298
- 505: 7/6/18: 0%->100 / Impacted TSs and TRs: 32.240; 32.260; 32.299; 32.298
- 506: 10/12/18: 0%->5; 10/12/18: 5%->; 10/12/18: WID:CP-181187->CP-183242 / Impacted TSs and TRs: 31.121 ; 31.124
- 507: 9/6/17: WID:SP-170058->SP-170583
- 508: 7/6/17: 0%->55; 11/9/17: 55%->90; 15/12/17: 90%->100
- 509: 7/6/17: 0%->60; 11/9/17: 60%->70; 15/12/17: 70%->100
- 510: 18/12/17: WID:CP-171045->CP-173038
- 511: 14/9/17: 0%->65; 15/12/17: 65%->100 / Impacted TSs and TRs: 24.301; 27.007
- 512: Impacted TSs and TRs: 29.212; 29.213; 29.214; 29.215; 29.201
- 513: 11/9/17: 0%->50; 15/12/17: 50%->100 / Impacted TSs and TRs: 23.008; 29.272; 29.230; 29.002; 29.305; 29.274
- 514: 15/12/17: 0%->20; 16/3/18: 20%->100 / Impacted TSs and TRs: 32.251; 32.298; 32.299
- 515: follow-up WI of REL-14 SI FS_NR_newRAT completed at RAN #75; 30/6/17: 38.425 added;; 14/9/17: WID:RP-170855->RP-171485; 15/12/17: added: 38.305; 38.113; 37.863-04-01; 37.863-03-01; 37.863-02-01; 38.820-04-01; 38.820-03-01; 38.820-02-01; 15/12/17: 37.32...; 6/8/18: 37.866-00-02 added; / Impacted TSs and TRs: 38.425; 38.424; 38.423; 38.422; 38.421; 38.420; 38.305; 38.113; 37.863-04-01; 37.863-03-01; 37.863-02-01; 38.820-04-01; 38.820-03-01; 38.820-02-01; 37.324; 37.872; 37.864-11-22; 37.866-00-02
- 516: follow-up WI of REL-14 SI FS_NR_newRAT; 19/6/17: Compl:0%->22%19/6/17: WID: RP-170855->RP-171485; 30/6/17 & 12/6/17: impacted specs added19/9/17: Compl:22%->50%19/9/17: WID: RP-171485->RP-172115; 15/12/17: added: 38.818; 37.865-01-01; 37.834-01-01; 37....; 6/8/18: 38.415 added; / Impacted TSs and TRs: 37.340;37.834-01-01;37.863-05-01;37.864-41-21;37.865-01-01;38.101;38.104;38.12?;38.201/2;38.211/2;38.213to215;38.300;38.304to307;38.321to323;38.331;38.401;38.410to414;38.455;38.470to475;38.815;38.817-01-02;38.818; 38.113; 29.413; 37.864-11-22; 38.415
- 517: follow-up WI of REL-14 SI FS_NR_newRAT completed at RAN #75; 19/6/17: WID: RP-170855->RP-171485; 12/7/17: 38.133 added;; 12/7/17: 38.141 added;; 19/9/17: WID: RP-171485->RP-172115; 15/12/17: 38.101-4 added; 8/1/18: WID: RP-172115->RP-172834; 27/3/18: W / Impacted TSs and TRs: 38.133; 38.141; 38.101-4; 38.171
- 518: no Perf. part; 14/9/17: WID:RP-170840->RP-171432
- 519: no Perf. Part19/6/17: Compl:0%->5%19/6/17: WID: RP-170840->RP-17143219/9/17: Compl:5%->10%; 8/1/18: Compl:10%->20%; 27/3/18: Compl:20%->30%; ; 27/6/18: Compl:30%->99%; 7/3/19: 99%->100
- 520: 16/1/19: 0%->100
- 521: ; 19/9/17: Compl:0%->2%; 15/12/17: impacted specs add; 15/12/17: 38.508-2 added;; ; / Impacted TSs and TRs: 38.507-1; 38.533; 38.522; 38.521-1-2-3; 38.508; 38.509; 38.903; 38.905; 38.523-1-2-3; ; 38.508-2
- 522: -

| ID | WBS | Task | Type | Duration | Start | Finish | Complete | Remaining | Total slack | Constraint | Resources | Work | Actual work | Acronym | PCG approved | WI rapporteur name | WI rapporteur e-mail | Release | TSG approved | Impacted TSs and TRs | Status Report |
| --- | --- | --- | --- | --- | --- | --- | --- | --- | --- | --- | --- | --- | --- | --- | --- | --- | --- | --- | --- | --- | --- |
| 523 | 263 | **Enhancement of 3GPP support for V2X scenarios** |  | 206d? | 2016-06-09 A | 2017-03-22 A | 100% |  |  |  |  | 1520h | 1520h | eV2X | 38 | Chun, SungDuck, LG Electronics | sungduck.chun@lge.com | Rel-15 | 75 |  |  |
| 524 | 263.1 | Study on Enhancement of 3GPP support for V2X services |  | 137d? | 2016-06-09 A | 2016-12-15 A | 100% |  |  | finish no earlier than 2016-12-15 | S1 | 1096h | 1096h | FS_eV2X | 37 | LG Electronics, SungDuck Chun | sungduck.chun@lge.com | Rel-15 | 72 | 22.886 |  |
| 525 | 263.2 | Stage 1 of Enhancement of 3GPP support for V2X scenarios |  | 53d? | 2017-01-09 A | 2017-03-22 A | 100% |  |  | finish no earlier than 2017-03-22 | S1 | 424h | 424h | eV2X | 38 | Chun, SungDuck, LG Electronics | sungduck.chun@lge.com | Rel-15 | 75 | 22.186 |  |
| 526 | 264 | **V2X new band combinations for LTE** |  | 328d? | 2017-03-15 A | 2018-06-15 A | 100% |  |  |  | R4 | 5248h | 5248h | LTE_V2X_CA_bands | 38 | LG Electronics |  | Rel-15 | 75 | 36.787 |  |
| 527 | 264.1 | Core part: V2X new band combinations for LTE |  | 328d? | 2017-03-15 A | 2018-06-15 A | 100% |  |  | finish no earlier than 2018-06-15 | R4 | 2624h | 2624h | LTE_V2X_CA_bands-Core | 38 | LG Electronics |  | Rel-15 | 75 |  |  |
| 528 | 265 | **Enhancements on LTE-based V2X Services** |  | 458d? | 2017-03-15 A | 2018-12-14 | 99% | 2.11d? | 26350d |  | R1 | 10472h | 10423.7h | LTE_eV2X | 38 | Huawei |  | Rel-15 | 75 |  |  |
| 529 | 265.1 | Core part: V2X phase 2 based on LTE |  | 393d? | 2017-03-15 A | 2018-09-14 | 99% | 3.93d? | 26415d | finish no earlier than 2018-09-15 | R1 | 3144h | 3112.56h | LTE_eV2X-Core | 38 | Huawei |  | Rel-15 | 75 | 36.788 | RP-180858 |
| 530 | 265.2 | Perf. Part: V2X phase 2 based on LTE |  | 458d? | 2017-03-15 A | 2018-12-14 A | 100% |  |  | finish no earlier than 2018-12-15 | R4 | 3664h | 3664h | LTE_eV2X-Perf | 38 | Huawei |  | Rel-15 | 75 |  |  |
| 531 | 266 | Study on security aspects for LTE support of V2X services |  | 465d? | 2015-09-07 A | 2017-06-15 A | 100% |  |  | finish no earlier than 2017-06-15 | S3 | 3720h | 3720h | FS_V2XLTE_ARC | 36 | Huawei, Marcus Wong | mwong@huawei.com | Rel-15 | 70 | TR 33.885 |  |
| 532 | 267 | Release 15 Features on Ultra/Highly Reliable Low Latency Communication | milestone | 0d? | 2016-06-09 A | 2016-06-09 A | 100% |  |  | finish no earlier than 2016-06-09 |  |  |  |  |  |  |  | Rel-15 |  |  |  |
| 533 | 268 | EPC support for E-UTRAN Ultra Reliable Low Latency Communication |  | 135d? | 2017-09-08 A | 2018-03-15 A | 100% |  |  | finish no earlier than 2018-03-15 | S2 | 1080h | 1080h | EPS_URLLC | 39 | Chris PUDNEY | chris dot pudney at vodafone dot com | Rel-15 | 77 | 23.401; 23.214; 23.203 |  |
| 534 | 269 | **Highly Reliable Low Latency Communication for LTE** |  | 458d? | 2017-03-15 A | 2018-12-15 | 46% | 248.61d? | 26350d |  | R1 | 10472h | 4787.71h | LTE_HRLLC | 38 | Ericsson |  | Rel-15 | 75 |  |  |
| 535 | 269.1 | Core part: Highly Reliable Low Latency Communication for LTE |  | 393d? | 2017-03-15 A | 2018-09-14 | 99% | 3.93d? | 26415d | finish no earlier than 2018-09-15 | R1 | 3144h | 3112.56h | LTE_HRLLC-Core | 38 | Ericsson |  | Rel-15 | 75 |  | RP-180693 |
| 536 | 269.2 | Perf. part: Highly Reliable Low Latency Communication for LTE |  | 458d? | 2017-03-15 | 2018-12-15 |  |  | 26350d | finish no earlier than 2018-12-15 | R4 | 3664h |  | LTE_HRLLC-Perf | 38 | Ericsson |  | Rel-15 | 75 |  |  |
| 537 | 270 | Release 15 Features on improvements of Mission Critical (MC) | milestone | 0d? | 2016-06-09 A | 2016-06-09 A | 100% |  |  | finish no earlier than 2016-06-09 |  |  |  |  |  |  |  | Rel-15 |  |  |  |
| 538 | 271 | Study on MC system migration and interconnect between MCPTT systems |  | 262d? | 2016-06-13 A | 2017-06-12 A | 100% |  |  | finish no earlier than 2017-06-12 | S6 | 2096h | 2096h | FS_MCSMI | 37 | Chater-Lea, David |  | Rel-15 | 72 | New TR 23.781 |  |
| 539 | 272 | Study on MC Communication Interworking between LTE and non-LTE Systems |  | 262d? | 2016-06-13 A | 2017-06-12 A | 100% |  |  | finish no earlier than 2017-06-12 | S6 | 2096h | 2096h | FS_MCCI | 37 | Monnes, Peter (Harris Corp.) |  | Rel-15 | 72 | New TR 23.782 |  |
| 540 | 273 | Study on MC Security Enhancements |  | 456d? | 2016-06-17 A | 2018-03-15 A | 100% |  |  | finish no earlier than 2018-03-15 | S3 | 3648h | 3648h | FS_MC_Sec | 37 | Haigh, Peter, CESG | peter.haigh@cesg.gsi.gov.uk | Rel-15 | 72 | TR 33.xxx; 33.280; 39.880 |  |
| 541 | 274 | MC Communication Interworking between LTE and non-LTE Systems (Stage 3 in Rel16) |  | 139d? | 2017-06-05 A | 2017-12-14 A | 100% |  |  | start no earlier than 2017-06-05 | S6 | 1112h | 1112h | MCCI | 39 | Monnes, Peter, Harris Corporation | pmonnes at harris dot com | Rel-15 | 76 | New TS 23.283; TS 23.280; TS 23.379; TS 23.282 |  |
| 542 | 275 | Removal of 'over LTE' limitation from Mission Critical Specifications |  | 23d? | 2017-11-15 A | 2017-12-15 A | 100% |  |  | finish no earlier than 2017-12-15 | S1 | 184h | 184h | MCOver | 40 | Kees Verweij ;The Police of the Netherlands | KeesdotVerweijatPolitiedotNL | Rel-15 | 78 | 22.179; 22.280; 22.281; 22.282; 22.468 |  |
| 543 | 276 | **Enhancements to MCPTT functional architecture and information flows** |  | 336d? | 2017-03-03 A | 2018-06-15 A | 100% |  |  |  |  | 3248h | 3248h | enhMCPTT | 38 | Dom Lazara, Motorola Solutions | dom.lazara@motorolasolutions.com | Rel-15 | 75 | TS 23.280 + TS 23.379 |  |
| 544 | 276.1 | Stage 2 of enhMCPTT |  | 205d? | 2017-03-03 A | 2017-12-14 A | 100% |  |  | finish no earlier than 2017-12-14 | S6 | 1640h | 1640h | enhMCPTT | 38 | Dom Lazara, Motorola Solutions | dom.lazara@motorolasolutions.com | Rel-15 | 75 | TS 23.280 + TS 23.379 |  |
| 545 | 276.2 | Stage 3 of enhMCPTT |  | 201d? | 2017-09-08 A | 2018-06-15 A | 100% |  |  | finish no earlier than 2018-06-15 | C1 | 1608h | 1608h | enhMCPTT-CT | 39 | FREDERICKS, Bob | bobfredericks@motorolasolutions.com | Rel-15 | 77 | 24.379; 24.380; 24.481; 24.482; 24.483; 24.484 |  |
| 546 | 277 | **Enhancements to MC Data Functional architecture and information flows** |  | 336d? | 2017-03-03 A | 2018-06-15 A | 100% |  |  |  |  | 3248h | 3248h | eMCData | 38 | David Freeman, Home Office | david@dnf-consulting.co.uk | Rel-15 | 75 | 23.280 + TS 23.282 |  |
| 547 | 277.1 | Stage 2 of eMCData |  | 205d? | 2017-03-03 A | 2017-12-14 A | 100% |  |  | finish no earlier than 2017-12-14 | S6 | 1640h | 1640h | eMCData | 38 | David Freeman, Home Office | david@dnf-consulting.co.uk | Rel-15 | 75 | 23.280 + TS 23.282 |  |
| 548 | 277.2 | Stage 3 of eMCData |  | 201d? | 2017-09-08 A | 2018-06-15 A | 100% |  |  | finish no earlier than 2018-06-15 | C1 | 1608h | 1608h | eMCData-CT | 39 | HASON, Baruh | Baruh.Hason@motorolasolutions.com | Rel-15 | 77 | 24.282; 24.582; 24.481; 24.483; 24.484 |  |

Notes:
- 524: 19/9/16: 30%->70; 6/10/16: 22.886 added; 1/12/16: 70%->95; 2/3/17: 95%->100
- 525: 7/6/17: 90%->100
- 526: no Perf. part; 12/7/17: 36.787 added;
- 527: no Perf. part; 19/6/17: Compl:0%->20%; 19/9/17: Compl:20%->40%; 8/1/18: Compl:40%->50%; 27/3/18: Compl:50%->70%;
- 528: follow-up WI of REL-14 WI LTE_V2X for which the Core part was completed at RAN #75; 14/9/17: WID:RP-170798->RP-171069
- 529: follow-up WI of REL-14 WI LTE_V2X for which the Core part was completed at RAN #75; 19/6/17: Compl:0%->15%; 30/6/17: 36.788 added;; 19/9/17: Compl:15%->30% 8/1/18: Compl:30%->55%27/3/18: Compl:55%->75%
- 530: follow-up WI of REL-14 WI LTE_V2X for which the Core part was completed at RAN #7519/6/17: WID: RP-170798->RP-17106919/9/17: WID: RP-171069->RP-171740; 27/6/18: Compl:0%->5%; 16/1/19: 5%->100; 16/1/19: WID:RP-171740->RP-182549
- 531: 11/12/15: WID:SP-150715->SP-150743. 28/01/16: typo on name corrected, WD corrected (was SP-150743); 7/3/16: 0%->10; 19/9/16: 10%->65; 1/12/16: 65%->85; 6/3/17: 85%->90; 21/3/17: FCD shifted, moved from Rel-14; 21/3/17: FCD:09/16->06/17; 8/8/18: 90%->100
- 532: -
- 533: 15/12/17: WID:SP-170797->SP-170811; 15/12/17: 0%->15; 20/3/18: 15%->100
- 534: 14/9/17: WID:RP-170796->RP-171489
- 535: ; 19/6/17: WID: RP-170796->RP-171489; 8/1/18: Compl:0%->10%; 8/1/18: WID: RP-171489->RP-172845; 27/3/18: Compl:10%->30%; 27/6/18: Compl:30%->99%; 27/6/18: CD:Fri 15
- 536: ; 19/6/17: WID: RP-170796->RP-171489; 8/1/18: WID: RP-171489->RP-172845; 27/6/18: WID: RP-172845->RP-181259
- 537: -
- 538: 28/7/16: 23.781 added; 19/9/16: WID:SP-160340->SP-160526; FCD: 09/16->12/16; 19/9/16: 0%->40; 1/12/16: WID:SP-160526->SP-160880; 1/12/16: 40%->48; 9/12/16: FCD:12/16->06/17, Rel-14->Rel-15; 3/3/17: 48%->60; 7/6/17: 60%->100
- 539: 28/7/16: 23.782 added; 19/9/16: WID:SP-160341->SP-160527; 19/9/16: 0%->20; 1/12/16: WID:SP-160527->SP-160881; 1/12/16: 20%->22; 9/12/16: FCD:12/16->06/17, Rel-14->Rel-15; 3/3/17: 22%->50; 7/6/17: 50%->90; 11/9/17: 90%->100
- 540: 28/7/16: 33.280 added; 28/7/16: 39.880 added; 19/9/16: WID:SP-160374->SP-160567. FCD: 12/16->03/17; 1/12/16: 0%->35; 6/3/17: FCD:03/17->06/17; 6/3/17: 35%->60; 7/6/17: FCD:06/17->12/17 (Rel-14->Rel-15);60%->65; 8/6/17: WID:SP-160567->SP-170416; 11/9/17
- 541: 11/9/17: 0%->40; 15/12/17: 40%->87; 16/3/18: 87%->100. 10/9/18: moved from Rel-15 since too late for St 3 in Rel-15 as said in CT81. 12/9/18: moved back to Rel-15, while St.3 will be Rel-16
- 542: 7/6/18: WID:SP-170986->SP-180354
- 543: 21/3/17: impacted TS/TR added; 7/6/17: 0%->25
- 544: 21/3/17: impacted TS/TR added; 7/6/17: 0%->25; 11/9/17: 25%->45; 15/12/17: 45%->100
- 545: 15/12/17: 0%->10; 7/6/18: 10%->20; 10/9/18: 20%->80; 7/12/18: 80%->85; 10/12/18: 85%->100
- 546: 21/3/17: impacted TS/TR added; 7/6/17: 0%->10; 8/6/17: WID:SP-170249->SP-170462
- 547: 21/3/17: impacted TS/TR added; 7/6/17: 0%->10; 8/6/17: WID:SP-170249->SP-170462; 11/9/17: 10%->15; 15/12/17: 15%->100
- 548: 20/3/18: 0%->30; 7/6/18: 30%->85; 10/12/18: 85%->100

| ID | WBS | Task | Type | Duration | Start | Finish | Complete | Remaining | Total slack | Constraint | Resources | Work | Actual work | Acronym | PCG approved | Impacted TSs and TRs | WI rapporteur name | WI rapporteur e-mail | Release | TSG approved | Status Report |
| --- | --- | --- | --- | --- | --- | --- | --- | --- | --- | --- | --- | --- | --- | --- | --- | --- | --- | --- | --- | --- | --- |
| 549 | 278 | **Enhancements to MC Video Functional architecture and information flows** |  | 270d? | 2017-06-05 A | 2018-06-15 A | 100% |  |  |  |  | 6042.8h | 6042.8h | eMCVideo | 39 | 23.280; 23.281 | Niranth Amogh, Huawei Telecommunications (India | namogh@huawei.com | Rel-15 | 76 |  |
| 550 | 278.1 | Stage 2 of eMCVideo |  | 139d? | 2017-06-05 A | 2017-12-14 A | 100% |  |  | finish no earlier than 2017-12-14 | S6 | 1112h | 1112h | eMCVideo | 39 | 23.280; 23.281 | Niranth Amogh, Huawei Telecommunications (India | namogh@huawei.com | Rel-15 | 76 |  |
| 551 | 278.2 | **Stage 3 of eMCVideo** |  | 201d? | 2017-09-08 A | 2018-06-15 A | 100% |  |  |  | ct | 4930.8h | 4930.8h | eMCVideo-CT | 39 |  | WEI, Haitao | weihaitao@huawei.com | Rel-15 | 77 |  |
| 552 | 278.2.1 | CT1 aspects of eMCVideo |  | 138.45d? | 2017-09-08 A | 2018-06-15 A | 100% |  |  | finish no earlier than 2018-06-15 | C1 | 1107.6h | 1107.6h | eMCVideo-CT | 39 | 24.281; 24.581; 24.481; 24.483; 24.484 | WEI, Haitao | weihaitao@huawei.com | Rel-15 | 77 |  |
| 553 | 278.2.2 | CT3 aspects of eMCVideo |  | 138.45d? | 2017-12-05 A | 2018-06-15 A | 100% |  |  | finish no earlier than 2018-06-15 | C3 | 1107.6h | 1107.6h | eMCVideo-CT | 39 | 29.165; 29.213; 29.214 | WEI, Haitao | weihaitao@huawei.com | Rel-15 | 77 |  |
| 554 | 278.2.3 | CT6 aspects of eMCVideo |  | 138.45d? | 2017-12-05 A | 2018-06-15 A | 100% |  |  | finish no earlier than 2018-06-15 | C6 | 1107.6h | 1107.6h | eMCVideo-CT | 39 | 31.102; 31.103 | WEI, Haitao | weihaitao@huawei.com | Rel-15 | 77 |  |
| 555 | 279 | MC Security Enhancements |  | 270d? | 2017-06-05 A | 2018-06-15 A | 100% |  |  | finish no earlier than 2018-06-15 | S3 | 2160h | 2160h | eMCSec | 39 | 33.180 | Haigh, Peter, NCSC |  | Rel-15 | 76 |  |
| 556 | 280 | MBMS usage for MC communication services |  | 330d? | 2017-03-03 A | 2018-06-07 A | 100% |  |  |  | S6 | 2640h | 2640h | MBMS_Mcservices | 38 | TS 23.280 + TS 23.281 + TS 23.282 + TS 23.379 | Magnus Tränk, Ericsson | magnus.trank@ericsson.com | Rel-15 | 75 |  |
| 557 | 281 | Stage 2 for MBMS_Mcservices |  | 206d? | 2017-03-03 A | 2017-12-15 A | 100% |  |  | finish no earlier than 2017-12-15 | S6 | 1648h | 1648h | MBMS_Mcservices | 38 | TS 23.280 + TS 23.281 + TS 23.282 + TS 23.379 | Magnus Tränk, Ericsson | magnus.trank@ericsson.com | Rel-15 | 75 |  |
| 558 | 282 | Stage 3 for MBMS_Mcservices |  | 44d? | 2018-04-09 A | 2018-06-07 A | 100% |  |  | finish no earlier than 2018-06-07 | C1 | 352h | 352h | MBMS_Mcservices_ | 41 | 24.281; 24.282; 24.379; 24.380; 24.581; 24.380 | Axell, Jörgen, Ericsson | Jorgen.Axell@ericsson.com | Rel-15 | 80 |  |
| 559 | 283 | MC system migration and interconnection |  | 139d? | 2017-06-05 A | 2017-12-14 A | 100% |  |  | start no earlier than 2017-06-05 | S6 | 1112h | 1112h | MCSMI | 39 | TS 23.280; TS 23.379; TS 23.281; TS 23.282; 24.885 | Chater-Lea, David; Motorola Solutions | david.chater-lea@motorolasolutions.com | Rel-15 | 76 |  |
| 560 | 284 | Protocol enhancements for Mission Critical Services |  | 201d? | 2017-09-08 A | 2018-06-15 A | 100% |  |  | finish no earlier than 2018-06-15 | C1 | 1608h | 1608h | MCProtoc15 | 39 |  | Jörgen Axell |  | Rel-15 | 77 |  |
| 561 | 285 | Release 15 Features on MTC-IoT | milestone | 0d? | 2016-06-09 A | 2016-06-09 A | 100% |  |  | finish no earlier than 2016-06-09 |  |  |  |  |  |  |  |  | Rel-15 |  |  |
| 562 | 286 | Battery Efficient Security for very low Throughput MTC Devices |  | 389d? | 2016-09-19 A | 2018-03-15 A | 100% |  |  | finish no earlier than 2018-03-15 | S3 | 3112h | 3112h | BEST_MTC_Sec | 37 | 33.401, 43.020, 33.220; 33.163 | Evans, Tim, VODAFONE Group Plc. |  | Rel-15 | 73 |  |
| 563 | 287 | AT Commands for CIoT-Ext |  | 130d? | 2017-12-15 A | 2018-06-14 A | 100% |  |  | finish no earlier than 2018-06-14 | C1 | 1040h | 1040h | AT_CIoT-Ext | 40 | 27.007 | Bakker, John-Luc (Blackberry) | jbakker@blackberry.com | Rel-15 | 78 |  |
| 564 | 288 | **Even further enhanced MTC for LTE** |  | 458d? | 2017-03-15 A | 2018-12-14 A | 100% |  |  |  | R1 | 10472h | 10472h | LTE_eMTC4 | 38 |  | Ericsson |  | Rel-15 | 75 |  |
| 565 | 288.1 | Core part: Even further enhanced MTC for LTE |  | 393d? | 2017-03-15 A | 2018-09-14 A | 100% |  |  | finish no earlier than 2018-09-15 | R1 | 3144h | 3144h | LTE_eMTC4-Core | 38 |  | Ericsson |  | Rel-15 | 75 | RP-181213 |
| 566 | 288.2 | Perf. part: Even further enhanced MTC for LTE |  | 458d? | 2017-03-15 A | 2018-12-14 A | 100% |  |  | finish no earlier than 2018-12-15 | R4 | 3664h | 3664h | LTE_eMTC4-Perf | 38 |  | Ericsson |  | Rel-15 | 75 |  |
| 567 | 289 | **Further NB-IoT enhancements** |  | 458d? | 2017-03-15 A | 2018-12-14 | 60% | 183.12d? | 26350d |  | R1 | 10472h | 6285.05h | NB_IOTenh2 | 38 |  | Huawei |  | Rel-15 | 75 |  |
| 568 | 289.1 | Core part: Further NB-IoT enhancements |  | 393d? | 2017-03-15 A | 2018-09-14 | 95% | 19.65d? | 26415d | finish no earlier than 2018-09-15 | R1 | 3144h | 2986.8h | NB_IOTenh2-Core | 38 |  | Huawei |  | Rel-15 | 75 | RP-180851 |
| 569 | 289.2 | Perf. part: Further NB-IoT enhancements |  | 458d? | 2017-03-15 A | 2018-12-14 | 30% | 320.6d? | 26350d | finish no earlier than 2018-12-15 | R4 | 3664h | 1099.2h | NB_IOTenh2-Perf | 38 |  | Huawei |  | Rel-15 | 75 |  |
| 570 | 290 | Release 15 Features related to WLAN | milestone | 0d? | 2016-06-09 A | 2016-06-09 A | 100% |  |  | finish no earlier than 2016-06-09 |  |  |  |  |  |  |  |  | Rel-15 |  |  |
| 571 | 291 | **Inclusion of WLAN direct discovery technologies as an alternative for ProSe direct discovery** |  | 348d? | 2016-11-15 A | 2018-03-15 A | 100% |  |  |  |  | 4528h | 4528h | ProSe_WLAN_DD | 38 | 22.278 | Intel Corporation; Ana Lucia Pinheiro | ana.lucia.a.pinheiro@intel.com | Rel-15 | 74 |  |
| 572 | 291.1 | Stage 1 of ProSe_WLAN_DD |  | 23d? | 2016-11-15 A | 2016-12-15 A | 100% |  |  | finish no earlier than 2016-12-15 | S1 | 184h | 184h | ProSe_WLAN_DD | 38 | 22.278 | Intel Corporation; Ana Lucia Pinheiro | ana.lucia.a.pinheiro@intel.com | Rel-15 | 74 |  |
| 573 | 291.2 | Stage 2 of ProSe_WLAN_DD |  | 76d? | 2017-03-02 A | 2017-06-15 A | 100% |  |  | finish no earlier than 2017-06-15 | S2 | 608h | 608h | ProSe_WLAN_DD_Stage2 | 38 |  | Intel, Sašo Stojanovski | saso.stojanovski@intel.com | Rel-15 | 75 |  |

Notes:
- 549: 7/6/17: 0%->10
- 550: 7/6/17: 0%->10; 11/9/17: 10%->60; 15/12/17: 60%->100
- 551: 7/6/18: WID:CP-172032->CP-181084
- 552: 20/3/18: 0%->25; 7/6/18: 25%->100; 12/6/18: 100%->99; 10/9/18: 99%->100
- 553: 10/9/18: 0%->100
- 554: 10/9/18: 0%->100
- 555: 15/12/17: 0%->80; 15/12/17: FCD:12/17->03/18; 21/12/17: FCD:03/18->05/18. Exception in SP-171056; 16/3/18: 80%->90; 16/3/18: FCD:05/18->06/18; 7/6/18: 90%->100
- 556: 21/3/17: impacted TS/TR added; 7/6/17: 0%->45; 8/9/17: WID:SP-170075->SP-170686; 8/9/17: FCD:09/17->12/17; 11/9/17: 45%->70; 15/12/17: 70%->95; 16/3/18: 95%->100. Problem with % complete when set as Parent Feature. Has to be left as independent item…
- 557: 21/3/17: impacted TS/TR added; 7/6/17: 0%->45; 8/9/17: WID:SP-170075->SP-170686; 8/9/17: FCD:09/17->12/17; 11/9/17: 45%->70; 15/12/17: 70%->95; 16/3/18: 95%->100
- 558: 12/6/18: 10%->30; 10/9/18: 30%->70; 7/12/18: 70%->100
- 559: 12/7/17: WID:SP-170402->SP-170577; 11/9/17: 0%->20; 15/12/17: 20%->80; 16/3/18: 80%->100
- 560: 14/9/17: 0%->15; 15/12/17: 15%->40; 20/3/18: 40%->70; 7/6/18: 70%->100
- 561: -
- 562: 6/10/16: 33.163 added 6/3/17: FCD:12/16->09/17; 6/3/17: 0%->20. Moved from Rel-14.; 7/6/17: 20%->95; 15/12/17: FCD:09/17->03/18; 16/3/18: 95%->100
- 563: 20/3/18: 0%->20; 7/6/18: 20%->100
- 564: WI LTE_feMTC-Core got a 3 months exception granted by RAN #75 to complete in REL-14; note: RAN #75 approved WID RP-170732 with working agreement; 14/9/17: WID:RP-170732->RP-171427
- 565: WI LTE_feMTC-Core got a 3 months exception granted by RAN #75 to complete in REL-14; note: RAN #75 approved WID RP-170732 with working agreement; 19/6/17: Compl:0%- 19/9/ 8/1 2 ;; 16/1/19: 97%->100
- 566: note: RAN #75 approved WID RP-170732 with working agreement19/6/17: WID: RP-170732->RP-171427; 8/1/18: WID: RP-171427->RP-172811; 27/6/18: Compl:0%->50%; 16/1/19: 50%->100
- 567: follow-up WI of REL-14 WI NB_IOTenh which got an exception granted at RAN #75 to complete by RAN #76; note: RAN #75 approved WID RP-170852 with working agreement; 14/9/17: WID:RP-170852->RP-171428
- 568: follow-up WI of REL-14 WI NB_IOTenh which got an exception granted at RAN #75 to complete by RAN #76; note: RAN #75 approved WID RP-170852 with working agreement;1 8/1/12 ;
- 569: follow-up WI of REL-14 WI NB_IOTenh which got an exception granted at RAN #75 to complete by RAN #76; note: RAN #75 approved WID RP-170852 with working agreement; 8/1 ;
- 570: -
- 571: 1/12/16: 0%->100
- 572: 1/12/16: 0%->100
- 573: 6/3/17: 0%->55; 7/6/17: 55%->100

| ID | WBS | Task | Type | Duration | Start | Finish | Complete | Constraint | Resources | Work | Actual work | Acronym | PCG approved | WI rapporteur name | WI rapporteur e-mail | Release | TSG approved | Impacted TSs and TRs |
| --- | --- | --- | --- | --- | --- | --- | --- | --- | --- | --- | --- | --- | --- | --- | --- | --- | --- | --- |
| 574 | 291.3 | **Stage 3 of ProSe_WLAN_DD** |  | 134d? | 2017-06-02 A | 2017-12-06 A | 100% |  | ct | 3216h | 3216h | ProSe_WLAN_DD_Stage3 | 39 | Intel, Vivek Gupta | vivek.g.gupta@intel.com | Rel-15 | 76 |  |
| 575 | 291.3.1 | CT1 aspects of ProSe_WLAN_DD |  | 134d? | 2017-06-02 A | 2017-12-06 A | 100% | finish no earlier than 2017-12-06 | C1 | 1072h | 1072h | ProSe_WLAN_DD_Stage3 | 39 | Intel, Vivek Gupta | vivek.g.gupta@intel.com | Rel-15 | 76 | 24.334 |
| 576 | 291.3.2 | CT4 aspects of ProSe_WLAN_DD |  | 134d? | 2017-06-02 A | 2017-12-06 A | 100% | finish no earlier than 2017-12-06 | C4 | 1072h | 1072h | ProSe_WLAN_DD_Stage3 | 39 | Intel, Vivek Gupta | vivek.g.gupta@intel.com | Rel-15 | 76 | 29.345; 29.230; 23.008 |
| 577 | 291.4 | Charging of ProSe_WLAN_DD |  | 65d? | 2017-12-15 A | 2018-03-15 A | 100% | finish no earlier than 2018-03-15 | S5 | 520h | 520h | ProSe_WLAN_DD-CH | 38 | Yizhi Yao, Intel Corporation | yizhi.yao@intel.com | Rel-15 | 74 | 32.277; 32.298; 32.299 |
| 578 | 292 | **Complementary Features for Voice services over WLAN** |  | 525d? | 2016-06-13 A | 2018-06-14 A | 100% |  |  | 10416h | 10416h | VoWLAN | 39 |  |  | Rel-15 | 76 |  |
| 579 | 292.1 | Study on Complementary Features for Voice services over WLAN |  | 199d? | 2016-06-13 A | 2017-03-15 A | 100% | finish no earlier than 2017-03-15 | S2 | 1592h | 1592h | FS_VoWLAN | 37 | Nokia (Nicolas Drevon | nicolas.drevon@nokia.com | Rel-15 | 72 | 23.751 |
| 580 | 292.2 | Stage 2 of VoWLAN |  | 23d? | 2017-05-09 A | 2017-06-08 A | 100% | finish no earlier than 2017-06-08 | S2 | 184h | 184h | VoWLAN | 39 | Drevon Nicolas, Nokia | nicolas.drevon@nokia.com | Rel-15 | 76 | 23.402 |
| 581 | 292.3 | **CT aspects of VoWLAN** |  | 270d? | 2017-06-02 A | 2018-06-14 A | 100% |  | ct | 8640h | 8640h | VoWLAN-CT | 39 | Jennifer Liu (Nokia) | Jennifer.Liu at nokia.com | Rel-15 | 76 |  |
| 582 | 292.3.1 | CT1 aspects of VoWLAN |  | 270d? | 2017-06-02 A | 2018-06-14 A | 100% | finish no earlier than 2018-06-14 | C1 | 2160h | 2160h | VoWLAN-CT | 39 | Jennifer Liu (Nokia) | Jennifer.Liu at nokia.com | Rel-15 | 76 | 24.302 ; 24.312 ; 24.244 |
| 583 | 292.3.2 | CT4 aspects of VoWLAN |  | 270d? | 2017-06-02 A | 2018-06-14 A | 100% | finish no earlier than 2018-06-14 | C4 | 2160h | 2160h | VoWLAN-CT | 39 | Jennifer Liu (Nokia) | Jennifer.Liu at nokia.com | Rel-15 | 76 | 29.274 |
| 584 | 292.3.3 | CT6 aspects of VoWLAN |  | 270d? | 2017-06-02 A | 2018-06-14 A | 100% | finish no earlier than 2018-06-14 | C6 | 2160h | 2160h | VoWLAN-CT | 39 | Jennifer Liu (Nokia) | Jennifer.Liu at nokia.com | Rel-15 | 76 | 31.102 |
| 585 | 293 | Release 15 Features on Virtual Reality (VR) | milestone | 0d? | 2016-03-01 A | 2016-03-01 A | 100% |  |  |  |  |  |  |  |  | Rel-15 |  |  |
| 586 | 294 | Study on Virtual Reality |  | 402d? | 2016-03-01 A | 2017-09-12 A | 100% | finish no earlier than 2017-09-12 | S4 | 3216h | 3216h | FS_VR | 36 | Gilles TENIOU, Orange | gilles.teniou@orange.com | Rel-15 | 71 | TR 26.918 |
| 587 | 295 | Study on 3GPP codecs for VR audio |  | 71d? | 2017-09-08 A | 2017-12-15 A | 100% | finish no earlier than 2017-12-15 | S4 | 568h | 568h | FS_CODVRA | 39 | Toftgård, Tomas, Ericsson | tomas.toftgard@ericsson.com | Rel-15 | 77 | 26.918 |
| 588 | 296 | Test Methodologies for the Evaluation of Perceived Listening Quality in Immersive Audio Systems |  | 266d? | 2017-09-08 A | 2018-09-14 A | 100% | finish no earlier than 2018-09-14 | S4 | 2128h | 2128h | LiQuImAS | 39 | Schevciw, Andre – Qualcomm Incorporated | aschevci@qti.qualcomm.com | Rel-15 | 77 | New; 26.861; 26.261; 26.260; 26.259 |
| 589 | 297 | Addition of HDR to TV Video Profiles |  | 71d? | 2017-09-08 A | 2017-12-15 A | 100% | finish no earlier than 2017-12-15 | S4 | 568h | 568h | HDR | 39 | Thomas Stockhammer, Qualcomm Incorporated | tsto@qti.qualcomm.com | Rel-15 | 77 | TS 26.116; TS 26.346; TS 26.234; TS 26.247; TS 26.244 |
| 590 | 298 | Virtual Reality Profiles for Streaming Media |  | 266d? | 2017-09-08 A | 2018-09-14 A | 100% | finish no earlier than 2018-09-14 | S4 | 2128h | 2128h | VRStream | 39 | Thomas Stockhammer, Qualcomm Incorporated | tsto@qti.qualcomm.com | Rel-15 | 77 | 26.118; 26.818; 26.247; 26.346; 26.234 |
| 591 | 299 | Release 15 other Features | milestone | 0d? | 2016-06-09 A | 2016-06-09 A | 100% |  |  |  |  |  |  |  |  | Rel-15 |  |  |
| 592 | 300 | Forward compatibility for 3GPP Diameter Charging Applications |  | 67d? | 2018-03-15 A | 2018-06-15 A | 100% | finish no earlier than 2018-06-15 | S5 | 536h | 536h | FWDCA | 40 | Gardella, Maryse, Nokia | maryse.gardella@nokia.com | Rel-15 | 79 | 32.251; 32.277; 32.299 |
| 593 | 301 | Diameter Overload Control Mechanisms for Charging |  | 132d? | 2018-03-15 A | 2018-09-14 A | 100% | finish no earlier than 2018-09-14 | S5 | 1056h | 1056h | DOCME_CH | 40 | Törnkvist, Robert, Ericsson | robert(dot)tornkvist(at)Ericsson(dot)com | Rel-15 | 79 | 32.299 |
| 594 | 302 | Charging aspects of WLAN access in EPC |  | 67d? | 2018-03-15 A | 2018-06-15 A | 100% | start no earlier than 2018-03-15 | S5 | 536h | 536h | WAEPC_CH | 40 | Gardella, Maryse, Nokia | maryse.gardella@nokia.com | Rel-15 | 79 | 32.251; 32.260; 32.299; 32.298 |
| 595 | 303 | FEC and ROHC Activation for GCSE over MBMS |  | 132d? | 2018-03-15 A | 2018-09-14 A | 100% | finish no earlier than 2018-09-14 | S4 | 1056h | 1056h | FRASE | 40 | Bouazizi, Imed, Samsung Electronics Co., Ltd | i.bouazizi@samsung.com. | Rel-15 | 79 | 26.346, new |
| 596 | 304 | Media Handling Aspects of 5G Conversational Services |  | 132d? | 2018-03-15 A | 2018-09-14 A | 100% | finish no earlier than 2018-09-14 | S4 | 1056h | 1056h | 5G_MTSI_Codecs | 40 | Oyman, Ozgur, Company: Intel | ozgur.oyman@intel.com | Rel-15 | 79 | 26.114; 26.223 |
| 597 | 305 | **SRVCC for terminating call in pre-alerting phase** |  | 66d? | 2018-03-15 A | 2018-06-14 A | 100% |  |  | 1056h | 1056h | bSRVCC_MT | 40 | Song Yue (China Mobile) | songyue (at) chinamobile (dot) com | Rel-15 | 79 |  |
| 598 | 305.1 | CT1 aspects of bSRVCC_MT |  | 66d? | 2018-03-15 A | 2018-06-14 A | 100% | start no earlier than 2018-03-15 | C1 | 528h | 528h | bSRVCC_MT | 40 | Song Yue (China Mobile) | songyue (at) chinamobile (dot) com | Rel-15 | 79 | 24.237; 24.008 |
| 599 | 305.2 | CT3 aspects of bSRVCC_MT |  | 66d? | 2018-03-15 A | 2018-06-14 A | 100% | start no earlier than 2018-03-15 | C3 | 528h | 528h | bSRVCC_MT | 40 | Song Yue (China Mobile) | songyue (at) chinamobile (dot) com | Rel-15 | 79 | 29.165 |

Notes:
- 574: 18/12/17: WID:CP-171102->CP-173084
- 575: 14/9/17: 0%->60; 15/12/17: 60%->100
- 576: 15/12/17: 0%->100
- 577: 15/12/17: 0%->40; 16/3/18: 40%->100
- 579: 28/7/16: 23.751 added; 19/9/16: 0%->10., 7/12/16: moved from Rel-14, according to SP-160806; 6/3/17: 10%->80; 7/6/17: 80%->100
- 580: 15/12/17: 0%->100
- 581: 7/6/18: WID:CP-171101->CP-181083
- 582: 14/9/17: 0%->70; 15/12/17: 70%->100
- 583: 7/6/18: 0%->100
- 584: 7/6/18: 0%->100
- 585: -
- 586: 11/6/16: 0%->10; 19/9/16: 10%->40, FCD: 12/16->03/17; 1/12/16: FCD:03/17->06/17; 1/12/16: 40%->35; 14/12/16: 35%->45; 14/12/16: FCD:06/17->09/17; 6/3/17: 45%->55; 7/6/17: 55%->70; 11/9/17: 70%->100
- 587: 15/12/17: 0%->100; 15/12/17: FCD:09/17->12/17
- 588: 15/12/17: added: 26.861; 26.261; 26.260; 26.259; 15/12/17: 0%->15; 16/3/18: 15%->20; 7/6/18: 20%->35; 7/6/18: FCD:06/18->09/18; 10/9/18: 35%->100
- 589: 15/12/17: 0%->100
- 590: 15/12/17: 26.118 added;; 15/12/17: 0%->25; 16/3/18: 25%->40; 7/6/18: 40%->60; 7/6/18: FCD:06/18->09/18; 10/9/18: 60%->100; 2/10/18: WID:SP-170612->SP-180893
- 591: -
- 592: 7/6/18: 0%->100
- 593: 7/6/18: 0%->10; 7/6/18: FCD:06/18->09/18; 10/9/18: 10%->100
- 594: 7/6/18: 0%->100
- 595: 7/6/18: 0%->30; 7/6/18: FCD:06/18->09/18; 10/9/18: 30%->100
- 596: 7/6/18: 0%->60; 7/6/18: FCD:06/18->09/18; 10/9/18: 60%->100; 2/10/18: WID:SP-180033->SP-180650
- 598: 16/3/18: 0%->80; 7/6/18: 80%->100
- 599: 22/3/18: 0%->95; 10/9/18: 95%->100

| ID | WBS | Task | Duration | Start | Finish | Complete | Remaining | Total slack | Constraint | Resources | Work | Actual work | Acronym | PCG approved | Impacted TSs and TRs | WI rapporteur name | WI rapporteur e-mail | Release | TSG approved | Status Report |
| --- | --- | --- | --- | --- | --- | --- | --- | --- | --- | --- | --- | --- | --- | --- | --- | --- | --- | --- | --- | --- |
| 600 | 306 | **Increasing the number of EPS bearers** | 66d? | 2018-03-16 A | 2018-06-15 A | 100% |  |  |  |  | 2112h | 2112h | INOBEAR | 40 | 23.401; 23.167 | Andy.Bennett, Samsung | a <dot> bennett <at> Samsung.com | Rel-15 | 78 |  |
| 601 | 306.1 | Stage 2 of INOBEAR | 66d? | 2018-03-16 A | 2018-06-15 A | 100% |  |  |  | S2 | 528h | 528h | INOBEAR | 40 | 23.401; 23.167 | Andy.Bennett, Samsung | a <dot> bennett <at> Samsung.com | Rel-15 | 78 |  |
| 602 | 306.2 | **Stage 3 of INOBEAR** | 66d? | 2018-03-16 A | 2018-06-15 A | 100% |  |  |  | ct | 1584h | 1584h | INOBEAR-CT | 40 |  | Samsung, Lalith Kumar | lalith.kumar@samsung.com | Rel-15 | 79 |  |
| 603 | 306.2.1 | CT1 aspects of INOBEAR | 66d? | 2018-03-16 A | 2018-06-15 A | 100% |  |  | start no earlier than 2018-03-16 | C1 | 528h | 528h | INOBEAR-CT | 40 | 24.301; 24.007 | Samsung, Lalith Kumar | lalith.kumar@samsung.com | Rel-15 | 79 |  |
| 604 | 306.2.2 | CT4 aspects of INOBEAR | 66d? | 2018-03-16 A | 2018-06-15 A | 100% |  |  | start no earlier than 2018-03-16 | C4 | 528h | 528h | INOBEAR-CT | 40 | 29.274 | Samsung, Lalith Kumar | lalith.kumar@samsung.com | Rel-15 | 79 |  |
| 605 | 307 | **Increased number of E-UTRAN data bearers** | 196d? | 2017-12-15 A | 2018-09-14 | 99% | 1.96d? | 26415d |  | R2 | 3136h | 3104.64h | INOBEARRAN | 40 |  | Samsung |  | Rel-15 | 78 |  |
| 606 | 307.1 | Core part: Increased number of E-UTRAN data bearers | 196d? | 2017-12-15 A | 2018-09-14 | 99% | 1.96d? | 26415d | finish no earlier than 2018-09-15 | R2 | 1568h | 1552.32h | INOBEARRAN-Core | 40 |  | Samsung |  | Rel-15 | 78 |  |
| 607 | 308 | **Remote UE access via relay UE** | 600d? | 2016-03-01 A | 2018-06-15 A | 100% |  |  |  |  | 4960h | 4960h | REAR | 36 | 22.278, 22.115 | Huawei, Laurence Meriau | laurence.meriau@huawei.com | Rel-15 | 71 |  |
| 608 | 308.1 | Study on architecture enhancements to ProSe UE-to-Network Relay | 206d? | 2016-12-01 A | 2017-09-14 A | 100% |  |  | finish no earlier than 2017-09-14 | S2 | 1648h | 1648h | FS_REAR | 38 | 23.733 | Dario Serafino Tonesi, Huawei | dario.tonesi@huawei.com | Rel-15 | 74 |  |
| 609 | 308.2 | Study on security aspects of enhancements to ProSe UE-to-Network Relay | 337d? | 2017-03-02 A | 2018-06-15 A | 100% |  |  | finish no earlier than 2018-06-15 | S3 | 2696h | 2696h | FS_REAR_Sec | 38 |  |  | lihe2@huawei.com | Rel-15 | 75 |  |
| 610 | 308.3 | Stage 1 for REAR | 77d? | 2016-03-01 A | 2016-06-15 A | 100% |  |  | finish no earlier than 2016-06-15 | S1 | 616h | 616h | REAR | 36 | 22.278, 22.115 | Huawei, Laurence Meriau | laurence.meriau@huawei.com | Rel-15 | 71 |  |
| 611 | 309 | **Enhanced VoLTE performance** | 402d? | 2016-12-01 A | 2018-06-15 A | 100% |  |  |  |  | 5680h | 5680h | eVoLP | 40 |  |  |  | Rel-15 | 78 |  |
| 612 | 309.1 | Stage 2 of eVoLP | 47d? | 2017-10-12 A | 2017-12-15 A | 100% |  |  | finish no earlier than 2017-12-15 | S2 | 376h | 376h | eVoLP | 40 | 23.401; 23.203 | Xiaobo Wu, Huawei | wuxiaobo@ huawei.com | Rel-15 | 78 |  |
| 613 | 309.2 | **CT aspects on enhanced VoLTE performance** | 130d? | 2017-12-15 A | 2018-06-14 A | 100% |  |  |  |  | 2080h | 2080h | eVoLP-CT | 40 |  | Yan, Yali, Huawei | yanyali@huawei.com | Rel-15 | 78 |  |
| 614 | 309.2.1 | CT3 aspects of EvoLP | 130d? | 2017-12-15 A | 2018-06-14 A | 100% |  |  | finish no earlier than 2018-06-14 | C3 | 1040h | 1040h | eVoLP-CT | 40 | 29.212; 29.213 | Yan, Yali, Huawei | yanyali@huawei.com | Rel-15 | 78 |  |
| 615 | 309.2.2 | CT4 aspects of EvoLP | 130d? | 2017-12-15 A | 2018-06-14 A | 100% |  |  | finish no earlier than 2018-06-14 | C4 | 1040h | 1040h | eVoLP-CT | 40 | 29.274 | Yan, Yali, Huawei | yanyali@huawei.com | Rel-15 | 78 |  |
| 616 | 309.3 | **Study on enhanced VoLTE performance** | 402d? | 2016-12-01 A | 2018-06-15 A | 100% |  |  |  |  | 3224h | 3224h | FS_eVoLP | 38 | 23.759 | Fabrice Plante, Intel | fabrice.m.plante@intel.com | Rel-15 | 74 |  |
| 617 | 309.3.1 | S2 aspects of FS_eVoLP | 206d? | 2016-12-01 A | 2017-09-14 A | 100% |  |  | finish no earlier than 2017-09-14 | S2 | 1648h | 1648h | FS_eVoLP | 38 | 23.759 | Xiaobo Wu |  | Rel-15 | 74 |  |
| 618 | 309.3.2 | S4 aspects of FS_eVoLP | 197d? | 2017-09-14 A | 2018-06-15 A | 100% |  |  | finish no earlier than 2018-06-15 | S4 | 1576h | 1576h | FS_eVoLP | 39 | 26.959 | Venkatraman, Atti, Qualcomm Incorporated | vatti@qti.qualcomm.com | Rel-15 | 77 |  |
| 619 | 310 | **Unlicensed Spectrum Offloading System** | 555d? | 2016-02-01 A | 2018-03-15 A | 100% |  |  |  |  | 2952h | 2952h | USOS | 36 |  | Edward Hall, Qualcomm Incorporated | edhall@qti.qualcomm.com | Rel-15 | 71 | SP-170526 |
| 620 | 310.1 | Study on unlicensed spectrum offloading system enhancements | 141d? | 2016-12-01 A | 2017-06-15 A | 100% |  |  | finish no earlier than 2017-06-15 | S2 | 1128h | 1128h | FS_USOS | 38 | TR 23.729 | Haris Zisimopoulos, Qualcomm Incorporated | harisz@qti.qualcomm.com | Rel-15 | 74 |  |
| 621 | 310.2 | Stage 1 of USOS | 22d? | 2016-02-01 A | 2016-03-01 A | 100% |  |  | start no earlier than 2016-02-01 | S1 | 176h | 176h | USOS | 36 | 22.101, 22.115 | Edward Hall, Qualcomm Incorporated | edhall@qti.qualcomm.com | Rel-15 | 71 | SP-170526 |
| 622 | 310.3 | Stage 2 of USOS | 71d? | 2017-09-08 A | 2017-12-15 A | 100% |  |  | finish no earlier than 2017-12-15 | S2 | 568h | 568h | USOS | 39 | TS 23.401; TS 23.203 | Haris Zisimopoulos | harisz@qti.qualcomm.com | Rel-15 | 77 |  |
| 623 | 310.4 | Stage 3 of USOS | 135d? | 2017-09-08 A | 2018-03-15 A | 100% |  |  | finish no earlier than 2018-03-15 | C4 | 1080h | 1080h | USOS-CT | 39 | 23.008; 29.272; 29.230; 29.002; 29.305; 29.274 | Lena Chaponniere, Qualcomm Incorporated | lguellec@qti.qualcomm.com | Rel-15 | 77 |  |

Notes:
- 603: 7/6/18: 0%->100
- 604: 7/6/18: 0%->100
- 606: 27/3/18: WID: RP-172835->RP-180569; 27/6/18: Compl:0%->99%; 27/6/18:
- 607: Previously known as "wearable devices"; 9/6/16: 0%->100; 9/6/16: WID:SP-160231->SP-160371
- 608: 1/12/16: 0%->5. Study on Stage 2 for REAR. When normative work completed, Stage 1 and Stage 2 shall be in the same release; 6/3/17: 5%->30; 7/6/17: 30%->60; 11/9/17: 60%->95; 15/12/17: 95%->100
- 609: 7/6/17: 0%->15; 11/9/17: 15%->50; 15/12/17: 50%->79; 16/3/18: 79%->99; 16/3/18: FCD:03/18->06/18; 7/6/18: 99%->100
- 610: Previously known as "wearable devices"; 9/6/16: 0%->100; 9/6/16: WID:SP-160231->SP-160371; 15/12/17: moved Rel-14->Rel-15
- 614: 16/3/18: 0%->100
- 615: 7/6/18: 0%->100
- 616: 1/12/16: 0%->5; 6/3/17: 5%->50; 7/6/17: 50%->60; 11/9/17: 60%->100
- 617: 1/12/16: 0%->5; 6/3/17: 5%->50; 7/6/17: 50%->60; 11/9/17: 60%->100; 15/12/17: rapporteur changed
- 618: 15/12/17: 26.959 added;; 15/12/17: 0%->50; 16/3/18: 50%->75; 16/3/18: FCD:03/18->06/18; 7/6/18: 75%->100
- 619: 08/09/17: Moved from Rel-14
- 620: 1/12/16: 0%->10; 6/3/17: 10%->30; 7/6/17: 30%->90; 11/9/17: 90%->100
- 622: 15/12/17: 0%->100
- 623: 15/12/17: acronym corrected to USOS-CT as per the approved WID; 18/12/17: 0%->60; 16/3/18: 60%->100

| ID | WBS | Task | Duration | Start | Finish | Complete | Constraint | Resources | Work | Actual work | Acronym | PCG approved | WI rapporteur name | WI rapporteur e-mail | Release | TSG approved |
| --- | --- | --- | --- | --- | --- | --- | --- | --- | --- | --- | --- | --- | --- | --- | --- | --- |
| 624 | 311 | **Mobile Communication System for Railways** | 528d? | 2016-06-09 A | 2018-06-15 A | 100% |  |  | 7440h | 7440h | MONASTERY | 38 | Merkel, Juergen, Nokia | juergen.merkel@nokia.com | Rel-15 | 75 |
| 625 | 311.1 | Study on Future Railway Mobile Communication System | 267d? | 2016-06-09 A | 2017-06-15 A | 100% | finish no earlier than 2017-06-15 | S1 | 2136h | 2136h | FS_FRMCS | 37 | Merkel, Juergen | Merkel, Juergen - Nokia Networks | Rel-15 | 72 |
| 626 | 311.2 | Study on Application Architecture for the Future Railway Mobile Communication System (stage 2) | 205d? | 2017-03-03 A | 2017-12-14 A | 100% | finish no earlier than 2017-12-14 | S6 | 1640h | 1640h | FS_FRMCS_ARCH | 38 | Oettl, Martin, Nokia | martin(dot)oettl(at)nokia(dot)com | Rel-15 | 75 |
| 627 | 311.3 | Stage 1 of MONASTERY | 76d? | 2017-03-02 A | 2017-06-15 A | 100% | finish no earlier than 2017-06-15 | S1 | 608h | 608h | MONASTERY | 38 | Merkel, Juergen, Nokia | juergen.merkel@nokia.com | Rel-15 | 75 |
| 628 | 311.4 | Stage 2 of MONASTERY | 71d? | 2017-09-08 A | 2017-12-15 A | 100% | finish no earlier than 2017-12-15 | S6 | 568h | 568h | MONASTERY | 39 | Oettl, Martin, Nokia | martin(dot)oettl(at)nokia(dot)com | Rel-15 | 77 |
| 629 | 311.5 | **Stage 3 of MONASTERY** | 66d? | 2018-03-16 A | 2018-06-15 A | 100% |  | ct | 2112h | 2112h | MONASTERY | 40 | Leis, Peter (Nokia) | peter(dot)leis(at)nokia(dot)com | Rel-15 | 79 |
| 630 | 311.5.1 | CT1 aspects of MONASTERY | 66d? | 2018-03-16 A | 2018-06-15 A | 100% | finish no earlier than 2018-06-15 | C1 | 528h | 528h | MONASTERY | 40 | Leis, Peter (Nokia) | peter(dot)leis(at)nokia(dot)com | Rel-15 | 79 |
| 631 | 311.5.2 | CT3 aspects of MONASTERY | 66d? | 2018-03-16 A | 2018-06-15 A | 100% | finish no earlier than 2018-06-15 | C3 | 528h | 528h | MONASTERY | 40 | Leis, Peter (Nokia) | peter(dot)leis(at)nokia(dot)com | Rel-15 | 79 |
| 632 | 311.5.3 | DELETED - CT6 aspects of MONASTERY | 66d? | 2018-03-16 A | 2018-06-15 A | 100% | finish no earlier than 2018-06-15 | C6 | 528h | 528h | MONASTERY | 40 | Leis, Peter (Nokia) | peter(dot)leis(at)nokia(dot)com | Rel-15 | 79 |
| 633 | 311.6 | Security Architecture of MONASTERY | 47d? | 2018-01-11 A | 2018-03-16 A | 100% | finish no earlier than 2018-06-15 | S3 | 376h | 376h | MONASTERY_SEC | 40 | Woodward, Tim, Motorola Solutions |  | Rel-15 | 79 |
| 634 | 312 | **PS Data Off Phase 2** | 336d? | 2017-03-02 A | 2018-06-14 A | 100% |  |  | 10296h | 10296h | PS_DATA_OFF2 | 38 | Murhammer, Leopold, Deutsche Telekom AG | leopold.murhammer@t-mobile.at | Rel-15 | 75 |
| 635 | 312.1 | Stage 2 of PS Data Off Phase 2 | 207d? | 2017-03-02 A | 2017-12-15 A | 100% | finish no earlier than 2017-12-15 | S2 | 1656h | 1656h | PS_DATA_OFF2 | 38 | Murhammer, Leopold, Deutsche Telekom AG | leopold.murhammer@t-mobile.at | Rel-15 | 75 |
| 636 | 312.2 | **Stage 3 of PS Data Off Phase 2** | 270d? | 2017-06-02 A | 2018-06-14 A | 100% |  | ct | 8640h | 8640h | PS_DATA_OFF2-CT | 39 | Herrero Veron, Christian (Huawei) | Christian.Herrero at huawei.com | Rel-15 | 76 |
| 637 | 312.2.1 | CT1 aspects of PS Data Off Phase 2 | 270d? | 2017-06-02 A | 2018-06-14 A | 100% | finish no earlier than 2018-06-14 | C1 | 2160h | 2160h | PS_DATA_OFF2-CT | 39 | Herrero Veron, Christian (Huawei) | Christian.Herrero at huawei.com | Rel-15 | 76 |
| 638 | 312.2.2 | CT4 aspects of PS Data Off Phase 2 | 270d? | 2017-06-02 A | 2018-06-14 A | 100% | finish no earlier than 2018-06-14 | C4 | 2160h | 2160h | PS_DATA_OFF2-CT | 39 | Herrero Veron, Christian (Huawei) | Christian.Herrero at huawei.com | Rel-15 | 76 |
| 639 | 312.2.3 | CT6 aspects of PS Data Off Phase 2 | 270d? | 2017-06-02 A | 2018-06-14 A | 100% | finish no earlier than 2018-06-14 | C6 | 2160h | 2160h | PS_DATA_OFF2-CT | 39 | Herrero Veron, Christian (Huawei) | Christian.Herrero at huawei.com | Rel-15 | 76 |
| 640 | 313 | **Northbound APIs for SCEF – SCS/AS Interworking** | 337d? | 2017-03-02 A | 2018-06-15 A | 100% |  |  | 10312h | 10312h | NAPS | 38 | Vaidya, Maulik, Huawei | Maulik.vaidya@huawei.com | Rel-15 | 75 |
| 641 | 313.1 | Stage 2 of NAPS | 142d? | 2017-03-02 A | 2017-09-15 A | 100% | start no earlier than 2017-03-02 | S2 | 1136h | 1136h | NAPS | 38 | Zhu Fenqin, Huawei | zhufenqin@huawei.com | Rel-15 | 75 |
| 642 | 313.2 | **Stage 3 of NAPS** | 270d? | 2017-06-02 A | 2018-06-14 A | 100% |  | C3 | 6480h | 6480h | NAPS-CT | 40 | Yan, Yali, Huawei, | yanyali@huawei.com | Rel-15 | 78 |
| 643 | 313.2.1 | CT3 aspects of NAPS | 270d? | 2017-06-02 A | 2018-06-14 A | 100% | finish no earlier than 2018-06-14 | C3 | 2160h | 2160h | NAPS-CT | 39 | Yan, Yali, Huawei, | yanyali@huawei.com | Rel-15 | 76 |
| 644 | 313.2.2 | CT4 aspects of NAPS | 270d? | 2017-06-02 A | 2018-06-14 A | 100% | finish no earlier than 2018-06-14 | C4 | 2160h | 2160h | NAPS-CT | 40 | Yan, Yali, Huawei, | yanyali@huawei.com | Rel-15 | 78 |
| 645 | 313.3 | Security aspects of NAPS | 136d? | 2017-09-08 A | 2018-03-16 A | 100% | finish no earlier than 2018-03-16 | S3 | 1088h | 1088h | NAPS-Sec | 39 | Zhao, Xuwen, Huawei | zhaoxuwen@huawei.com | Rel-15 | 77 |
| 646 | 313.4 | Carging aspects of NAPS | 201d? | 2017-09-08 A | 2018-06-15 A | 100% | finish no earlier than 2018-06-15 | S5 | 1608h | 1608h | NAPS-CH | 39 | Chen, Shan, Huawei | chenshan@huawei.com | Rel-15 | 76 |
| 647 | 314 | **Common API Framework for 3GPP Northbound APIs** | 331d? | 2017-03-10 A | 2018-06-15 A | 100% |  |  | 3216h | 3216h | CAPIF | 39 | Suresh Chitturi, Samsung | s.chitturi@samsung.com | Rel-15 | 77 |
| 648 | 314.1 | Study on CAPIF | 135d? | 2017-03-10 A | 2017-09-14 A | 100% | finish no earlier than 2017-09-14 | S6 | 1080h | 1080h | FS_CAPIF | 38 | Suresh Chitturi, Samsung | s.chitturi@samsung.com | Rel-15 | 75 |
| 649 | 314.2 | Stage 2 of CAPIF | 71d? | 2017-09-08 A | 2017-12-15 A | 100% | finish no earlier than 2017-12-15 | S6 | 568h | 568h | CAPIF | 39 | Suresh Chitturi, Samsung | s.chitturi@samsung.com | Rel-15 | 77 |
| 650 | 314.3 | Stage 3 of CAPIF | 66d? | 2018-03-16 A | 2018-06-15 A | 100% | finish no earlier than 2018-06-15 | C3 | 528h | 528h | CAPIF-CT | 40 | Nishant Gupta, Samsung | nishant.gup@samsung.com | Rel-15 | 79 |
| 651 | 314.4 | Security aspects of CAPIF | 130d? | 2017-12-15 A | 2018-06-14 A | 100% | finish no earlier than 2018-06-14 | S3 | 1040h | 1040h | CAPIF-Sec | 40 | Rajavelsamy Rajadurai, Samsung | rajvel{@]samsung.com | Rel-15 | 78 |

Notes:
- 625: 19/9/16: 0%->25; 6/10/16: 22.989 added; 1/12/16: 25%->40; 1/12/16: WID:SP-160371->SP-160903; 9/12/16: FCD:12/16->3/201. WID was in SP-160903; 2/3/17: 40%->80; 2/3/17: FCD:03/17->06/17; 7/6/17: 80%->100 / Impacted TSs and TRs: 22.989
- 626: 21/3/17: added impacted TR; 7/6/17: 0%->10; 11/9/17: 10%->50; 15/12/17: 50%->100 / Impacted TSs and TRs: new TR 23.790
- 627: 7/6/17: 0%->10; 8/9/17: WID:SP-170163->SP-170697; 11/9/17: 10%->100 / Impacted TSs and TRs: 22.280; 22.179
- 628: 14/9/17: SA6 and not SA2; 15/12/17: 0%->100 / Impacted TSs and TRs: 23.280; 23.379
- 629: 10/9/18: WID:CP-180097->CP-182202
- 630: 16/3/18: 0%->40; 7/6/18: 40%->85; 10/9/18: 85%->100 / Impacted TSs and TRs: 24.379; 24.380; 24.481; 24.483; 24.484
- 631: 10/9/18: 0%->100 / Impacted TSs and TRs: 29.165
- 632: 10/9/18: 0%->100 / Impacted TSs and TRs: 31.102; 31.103
- 633: 16/3/18: 0%->100 / Impacted TSs and TRs: 33.180
- 635: 7/6/17: 0%->10; 11/9/17: 10%->85; 15/12/17: 85%->100; 15/12/17: FCD:09/17->12/17
- 636: 18/12/17: WID:CP-171104->CP-173162; 7/6/18: WID:CP-173162->CP-181082
- 637: 7/6/18: 0%->100 / Impacted TSs and TRs: 24.008; 24.301; 27.007; 24.229; 24.368; 24.167; 24.173; 24.275; 24.341; 24.390; 24.391
- 638: 15/12/17: 0%->100 / Impacted TSs and TRs: 29.272; 29.274; 29.328; 29.329; 29.228; 29.229; 23.008
- 639: 7/6/18: 0%->100 / Impacted TSs and TRs: 31.102; 31.103; 31.111
- 640: 6/3/17: 0%->10
- 641: 6/3/17: 0%->10; 7/6/17: 10%->85; 30/6/17: 29.122 added;; 11/9/17: 85%->100; 15/12/17: rapoprteur changed / Impacted TSs and TRs: 29.122
- 642: 5/6/17: 0%->25; 8/9/17: WID:CP-171143->CP-172057; 11/9/17: 25%->40; 11/9/17: 40%->90. 18/12/17: WID corrected; 18/12/17: WID:CP-171143 ->CP-173112 / Impacted TSs and TRs: 29.336; 29.128; 29.230
- 643: 5/6/17: 0%->25; 8/9/17: WID:CP-171143->CP-172057; 11/9/17: 25%->40; 11/9/17: 40%->90; 15/12/17: 90%->65. 18/12/17: WID corrected; 16/3/18: 65%->72; 7/6/18: 72%->85; 7/6/18: 85%->95; 10/9/18: 95%->100 / Impacted TSs and TRs: 29.336; 29.128; 29.230
- 644: 7/6/18: 95%->100
- 645: 15/12/17: 0%->60; 16/3/18: 60%->100 / Impacted TSs and TRs: 33.187
- 646: 30/6/17: 32.254 added;; 11/9/17: 0%->10; 15/12/17: 10%->20; 16/3/18: 20%->50; 7/6/18: 50%->100 / Impacted TSs and TRs: New TS; impact 32.240; 32.298; 32.299; 32.254
- 647: 15/12/17: 23.222 added; / Impacted TSs and TRs: New; 23.222
- 648: 21/3/17: added impacted TR; 7/6/17: 0%->35; 8/6/17: WID:SP-170279->SP-170405; 11/9/17: 35%->70; 15/12/17: 70%->100 / Impacted TSs and TRs: new TR 23.722
- 649: 15/12/17: 0%->95; 16/3/18: 95%->100 / Impacted TSs and TRs: New
- 650: 16/3/18: 0%->10; 27/3/18: 29.222 added; 19/4/18: CAPIF->CAPIF-CT; 7/6/18: 10%->35; 7/6/18: 35%->85; 10/9/18: 85%->100 / Impacted TSs and TRs: 29.122; 29.116; 29.222
- 651: 16/3/18: 0%->40; 7/6/18: 40%->100

| ID | WBS | Task | Duration | Start | Finish | Complete | Constraint | Resources | Work | Actual work | Acronym | PCG approved | WI rapporteur name | WI rapporteur e-mail | Release | TSG approved | Status Report |
| --- | --- | --- | --- | --- | --- | --- | --- | --- | --- | --- | --- | --- | --- | --- | --- | --- | --- |
| 652 | 315 | **Management and orchestration of 5G networks and network slicing** | 591d? | 2016-06-13 A | 2018-09-14 A | 100% |  | S5 | 23664h | 23664h | NETSLICE | 39 | Jan Groenendijk, Ericsson | jan<dot>groenendijk<at>ericsson<dot>com | Rel-15 | 76 |  |
| 653 | 315.1 | General aspects of NETSLICE | 591d? | 2016-06-13 A | 2018-09-14 A | 100% | finish no earlier than 2018-09-14 | S5 | 4728h | 4728h | NETSLICE | 39 | Jan Groenendijk, Ericsson | jan<dot>groenendijk<at>ericsson<dot>com | Rel-15 | 76 |  |
| 654 | 315.2 | Study on management and orchestration of network slicing for next generation network | 328d? | 2016-06-13 A | 2017-09-12 A | 100% | finish no earlier than 2017-09-12 | S5 | 2624h | 2624h | FS_MONETS | 37 | Ericsson , Robert Petersen |  | Rel-15 | 72 |  |
| 655 | 315.3 | Study on security aspect of 5G Network Slicing Provisioning | 201d? | 2017-09-08 A | 2018-06-15 A | 100% | finish no earlier than 2018-06-15 | S3 | 1608h | 1608h | FS_NETSLICE_MGT_Sec | 39 | SA3: Huawei | lei.zhongding@huawei.com | Rel-15 | 77 |  |
| 656 | 315.4 | Provisioning of network slicing for 5G networks and services | 335d? | 2017-06-05 A | 2018-09-14 A | 100% | finish no earlier than 2018-09-14 | S5 | 2680h | 2680h | NETSLICE-PRO_NS | 39 | Zhang Kai, Huawei | kai.zhangkai@huawei.com | Rel-15 | 76 |  |
| 657 | 315.5 | Network Resource Model (NRM) for 5G networks and network slicing | 196d? | 2017-12-15 A | 2018-09-14 A | 100% | finish no earlier than 2018-09-14 | S5 | 1568h | 1568h | NETSLICE-5GNRM | 40 | Nokia (Jing Ping | jing.ping@nokia-sbell.com | Rel-15 | 78 |  |
| 658 | 315.6 | Performance Assurance for 5G networks including network slicing | 196d? | 2017-12-15 A | 2018-09-14 A | 100% | finish no earlier than 2018-09-14 | S5 | 1568h | 1568h | NETSLICE-ADPM5G | 40 | Yizhi Yao, Intel Corporation | yizhi dot yao at intel dot com | Rel-15 | 78 |  |
| 659 | 315.7 | Management and virtualization aspects of 5G networks | 196d? | 2017-12-15 A | 2018-09-14 A | 100% | finish no earlier than 2018-09-14 | S5 | 1568h | 1568h | NETSLICE-MNFV5G | 40 | Joey Chou, Intel | joey<dot>chou<at>intel<dot>com | Rel-15 | 78 |  |
| 660 | 315.8 | 5G Trace management | 125d? | 2017-12-15 A | 2018-06-07 A | 100% | finish no earlier than 2018-06-07 | S5 | 1000h | 1000h | NETSLICE-5GTRACE | 40 | Nokia (Anatoly Andrianov | anatoly.andrianov@nokia.com | Rel-15 | 78 |  |
| 661 | 315.9 | **CT aspects of 5G Trace management** | 1d? | 2018-09-06 A | 2018-09-06 A | 100% |  | ct | 24h | 24h | NETSLICE-5GTRACE-CT | 41 | Landais, Bruno, Nokia | bruno.landais@nokia.com | Rel-15 | 81 |  |
| 662 | 315.9.1 | CT3 aspects of 5G Trace management | 1d? | 2018-09-06 A | 2018-09-06 A | 100% | start no earlier than 2018-09-06 | C3 | 8h | 8h | NETSLICE-5GTRACE-CT | 41 | Landais, Bruno, Nokia | bruno.landais@nokia.com | Rel-15 | 81 |  |
| 663 | 315.9.2 | CT4 aspects of 5G Trace management | 1d? | 2018-09-06 A | 2018-09-06 A | 100% | start no earlier than 2018-09-06 | C4 | 8h | 8h | NETSLICE-5GTRACE-CT | 41 | Landais, Bruno, Nokia | bruno.landais@nokia.com | Rel-15 | 81 |  |
| 664 | 315.10 | Fault Supervision for 5G networks and network slicing | 196d? | 2017-12-15 A | 2018-09-14 A | 100% | finish no earlier than 2018-09-14 | S5 | 1568h | 1568h | NETSLICE-FS5G | 40 | Zhu Weihong, ZTE | zhu.weihong@zte.com.cn | Rel-15 | 78 |  |
| 665 | 316 | **Policy and Charging for Volume Based Charging** | 402d? | 2016-12-01 A | 2018-06-15 A | 100% |  |  | 7584h | 7584h | PC_VBC | 40 |  |  | Rel-15 | 78 |  |
| 666 | 316.1 | **Study on Policy and Charging for Volume Based Charging** | 272d? | 2016-12-01 A | 2017-12-15 A | 100% |  | C3 | 6528h | 6528h | FS_PC_VBC | 38 | Huang, Zhenning, China Mobile | huangzhenning <at> chinamobile <dot> com | Rel-15 | 74 |  |
| 667 | 316.1.1 | CT3 aspects of FS_PC_VBC | 272d? | 2016-12-01 A | 2017-12-15 A | 100% | finish no earlier than 2017-12-15 | C3 | 2176h | 2176h | FS_PC_VBC | 38 | Huang, Zhenning, China Mobile | huangzhenning <at> chinamobile <dot> com | Rel-15 | 74 |  |
| 668 | 316.1.2 | CT1 aspects of FS_PC_VBC | 272d? | 2016-12-01 A | 2017-12-15 A | 100% | finish no earlier than 2017-12-15 | C1 | 2176h | 2176h | FS_PC_VBC | 38 | Huang, Zhenning, China Mobile | huangzhenning <at> chinamobile <dot> com | Rel-15 | 74 |  |
| 669 | 316.2 | CT1 aspects of PV_VBC | 66d? | 2018-03-16 A | 2018-06-15 A | 100% | finish no earlier than 2018-06-15 | C1 | 528h | 528h | PC_VBC | 40 | Huang Zhenning (China Mobile) | huangzhenning (at) chinamobile (dot) com | Rel-15 | 79 |  |
| 670 | 316.3 | CT3 aspects of PV_VBC | 66d? | 2018-03-16 A | 2018-06-15 A | 100% | finish no earlier than 2018-06-15 | C3 | 528h | 528h | PC_VBC | 40 | Huang Zhenning (China Mobile) | huangzhenning (at) chinamobile (dot) com | Rel-15 | 79 |  |
| 671 | 317 | Framework for Live Uplink Streaming | 269d? | 2017-06-05 A | 2018-06-14 A | 100% | finish no earlier than 2018-06-14 | S4 | 2152h | 2152h | FLUS | 39 | Park, Kyungmo, SK Telecom | kyungmo.park@sk.com | Rel-15 | 76 |  |
| 672 | 318 | Self-Organizing Networks (SON) for Active Antenna System (AAS) deployment management | 201d? | 2017-09-08 A | 2018-06-15 A | 100% | finish no earlier than 2018-06-15 | S5 | 1608h | 1608h | OAM_SON_AAS | 39 | Nokia (Weixing Wang) | weixing.wang@nokia-sbell.com | Rel-15 | 77 |  |
| 673 | 319 | Server and Network Assisted DASH for 3GPP Multimedia Services | 206d? | 2016-12-01 A | 2017-09-14 A | 100% | finish no earlier than 2017-09-14 | S4 | 1648h | 1648h | SAND | 38 | Ozgur Oyman, Intel | ozgur.oyman@intel.com | Rel-15 | 74 | SP-170687 |
| 674 | 320 | SAND for MBMS | 201d? | 2017-09-08 A | 2018-06-15 A | 100% | finish no earlier than 2018-06-15 | S4 | 1608h | 1608h | SAND4M | 39 | Thomas Stockhammer, Qualcomm Incorporated | tsto@qti.qualcomm.com | Rel-15 | 77 |  |
| 675 | 321 | Management Enhancement for EPC CUPS | 196d? | 2017-12-15 A | 2018-09-14 A | 100% | finish no earlier than 2018-09-14 | S5 | 1568h | 1568h | ME_CUPS | 40 | Huawei (ZHU, Lei | lei.zhu@huawei.com | Rel-15 | 78 |  |
| 676 | 322 | Enhanced QoE Reporting for MTSI | 204d? | 2017-06-05 A | 2018-03-15 A | 100% | finish no earlier than 2018-03-15 | S4 | 1632h | 1632h | EQoE_MTSI | 39 | Gunnar Heikkilä, Ericsson LM | gunnar.heikkila@ericsson.com | Rel-15 | 76 |  |

Notes:
- 652: 21/12/17: WID:SP-170586->SP-170960. Name changed from "Management of Network Slicing in Mobile Networks, Concepts, Use cases and Requirements"; 27/3/18: 32.159 added;; 6/8/18: 32.159 added;; 8/8/18: WID:SP-170960->SP 180124; 2/10/18: WID:SP 180124->SP-180816 / Impacted TSs and TRs: 32.101; 32.103; new; 32.159; 32.159
- 653: 21/12/17: created from the Feature level, since SP-170960 contains its own specs and completions; 16/3/18: 46%->60; 7/6/18: 60%->85; 7/6/18: FCD:06/18->09/18; 8/8/18: WID:SP-170960->SP 180124; 10/9/18: 85%->100 / Impacted TSs and TRs: 32.101; 32.103; 28.530
- 654: 28/7/16: 28.801 added; 19/9/16: 0%->10; 1/12/16: 10%->25; 6/3/17: FCD:03/17->06/17; 6/3/17: 25%->60; 21/3/17: moved from rel-14; 7/6/17: FCD:06/17->09/17; 7/6/17: 60%->90; 11/9/17: 90%->100 / Impacted TSs and TRs: 32.8xx; 28.801
- 655: 11/9/17: 0%->5; 15/12/17: 33.811 added;; 15/12/17: 5%->20. Acronym corrected.; 16/3/18: 20%->30; 7/6/18: 30%->100 / Impacted TSs and TRs: 33.811
- 656: 15/12/17: 0%->15; 21/12/17: WID:SP-170580->SP-170955; 16/3/18: 15%->40; 27/3/18: 28.532 added;; 7/6/18: 40%->80; 7/6/18: FCD:06/18->09/18; 10/9/18: 80%->100; 2/10/18: WID:SP-170955->SP-180818 / Impacted TSs and TRs: 28.531
- 657: 16/3/18: 0%->25; 7/6/18: 25%->60; 7/6/18: FCD:06/18->09/18; 10/9/18: 60%->100; 2/10/18: WID:SP-170956->SP-180812 / Impacted TSs and TRs: 28.657; 28.658; 28.659; 28.707; 28.708; 28.709
- 658: 16/3/18: 0%->10; 7/6/18: 10%->50; 7/6/18: FCD:06/18->09/18; 10/9/18: 50%->100; 2/10/18: WID:SP-170957->SP-180814 / Impacted TSs and TRs: 32.404
- 659: 16/3/18: 0%->25; 7/6/18: 25%->75; 7/6/18: FCD:06/18->09/18; 10/9/18: 75%->100 / Impacted TSs and TRs: 28.500; 28.510; 28.511; 28.512; 28.513; 28.515; 28.516; 28.517; 28.518; 28.520; 28.521; 28.522; 28.523; 28.525; 28.526; 28.527; 28.528
- 660: 7/6/18: 0%->100 / Impacted TSs and TRs: 32.421; 32.422; 32.423; 32.441; 32.442; 32.446
- 662: 10/9/18: 0%->100 / Impacted TSs and TRs: 29.507; 29.512
- 663: 10/9/18: 0%->100 / Impacted TSs and TRs: 29.502; 29.503; 29.505; 29.509; 29.518; 29.540; 29.571; 29.244; 29.274
- 664: 16/3/18: 0%->20; 7/6/18: 20%->60; 7/6/18: FCD:06/18->09/18; 10/9/18: 60%->100; 2/10/18: WID:SP-170961->SP-180817 / Impacted TSs and TRs: 28.545
- 666: 6/3/17: 0%->30; 21/3/17: 29.827 added;; 5/6/17: 30%->60; 8/9/17: WID:CP-160822->CP-172058; 11/9/17: FCD:06/17->12/17 / Impacted TSs and TRs: TR 29.827
- 667: 6/3/17: 0%->30; 21/3/17: 29.827 added;; 5/6/17: 30%->60; 8/9/17: WID:CP-160822->CP-172058; 11/9/17: FCD:06/17->12/17; 15/12/17: 60%->61; 15/12/17: 61%->100 / Impacted TSs and TRs: TR 29.827
- 668: 15/12/17: 0%->100 / Impacted TSs and TRs: TR 29.827
- 669: 7/6/18: 0%->100 / Impacted TSs and TRs: 24.605; 24.147
- 670: 7/6/18: 0%->100 / Impacted TSs and TRs: 29.212; 29.213; 29.214
- 671: 30/6/17: 26.238 added;; 11/9/17: 0%->10; 15/12/17: 10%->85; 15/12/17: FCD:12/17->06/18; 21/12/17: WID:SP-170576->SP-170824; 16/3/18: 85%->90; 7/6/18: 90%->100 / Impacted TSs and TRs: New TS; 26.238
- 672: 15/12/17: 0%->80; 10/9/18: 80%->100 / Impacted TSs and TRs: 28.627; 28.628; 28.629; 28.658; 28.659
- 673: 3/3/17: WID:SP-160779->SP-170031; 6/3/17: 0%->15; 7/6/17: 15%->60; 11/9/17: 60%->100 / Impacted TSs and TRs: TS 26.247, 26.233
- 674: 15/12/17: 0%->50; 15/12/17: FCD:12/17->03/18; 21/12/17: WID:SP-170608->SP-170827; 16/3/18: 50%->60; 16/3/18: FCD:03/18->06/18; 7/6/18: 60%->100 / Impacted TSs and TRs: TS 26.247; TS 26.346; TS 26.347; TR26.946
- 675: ASN.1-type of WID, hence later than St3, indpt of CUPS Rel-14; 16/3/18: 0%->5; 7/6/18: 5%->60; 10/9/18: 60%->100 / Impacted TSs and TRs: 32.426; 32.455; 28.658; 28.707; 28.708; 28.709
- 676: 11/9/17: 0%->10; 15/12/17: 10%->80; 16/3/18: 80%->100 / Impacted TSs and TRs: TS 26.114

| ID | WBS | Task | Duration | Start | Finish | Complete | Remaining | Total slack | Constraint | Resources | Work | Actual work | Acronym | PCG approved | WI rapporteur name | Release | TSG approved | WI rapporteur e-mail | TSG stopped | Status Report |
| --- | --- | --- | --- | --- | --- | --- | --- | --- | --- | --- | --- | --- | --- | --- | --- | --- | --- | --- | --- | --- |
| 677 | 323 | **Enhanced Calling Name Service** | 390d? | 2016-09-15 A | 2018-03-14 A | 100% |  |  |  |  | 5424h | 5424h | eCNAM | 37 | Hala Mowafy, Ericsson | Rel-15 | 73 |  |  |  |
| 678 | 323.1 | Stage 1 of eCNAM | 66d? | 2016-09-15 A | 2016-12-15 A | 100% |  |  | finish no earlier than 2016-12-15 | S1 | 528h | 528h | eCNAM | 37 | Hala Mowafy, Ericsson | Rel-15 | 73 |  |  |  |
| 679 | 323.2 | **CT aspects of eCNAM** | 204d? | 2017-06-02 A | 2018-03-14 A | 100% |  |  |  | ct | 4896h | 4896h | eCNAM-CT | 39 | Mowafy, Hala. Ericsson | Rel-15 | 76 | hala.mowafy@ericsson.com |  |  |
| 680 | 323.2.1 | CT1 aspects of eCNAM | 204d? | 2017-06-02 A | 2018-03-14 A | 100% |  |  | finish no earlier than 2018-03-14 | C1 | 1632h | 1632h | eCNAM-CT | 39 | Mowafy, Hala. Ericsson | Rel-15 | 76 | hala.mowafy@ericsson.com |  |  |
| 681 | 323.2.2 | CT3 aspects of eCNAM | 204d? | 2017-06-02 A | 2018-03-14 A | 100% |  |  | finish no earlier than 2018-03-14 | C3 | 1632h | 1632h | eCNAM-CT | 39 | Mowafy, Hala. Ericsson | Rel-15 | 76 | hala.mowafy@ericsson.com |  |  |
| 682 | 324 | Enhancement of background data transfer | 38d? | 2017-01-16 A | 2017-03-08 A | 100% |  |  | finish no earlier than 2017-03-08 | S1 | 304h | 304h | eBT | 38 | Atsushi Minokuchi, NTT DOCOMO | Rel-15 | 75 | minokuchi at nttdocomo dot com |  |  |
| 683 | 325 | **Stage-3 SAE Protocol Development - Phase 6** | 272d? | 2017-06-02 A | 2018-06-18 A | 100% |  |  |  | C1 | 8704h | 8704h | SAES6 | 39 | Interdigital, Aghili, Behrouz | Rel-15 | 76 | Behrouz.aghili@interdigital.com |  |  |
| 684 | 325.1 | SAES6 CS Fallback in EPS | 272d? | 2017-06-02 A | 2018-06-18 A | 100% |  |  | start no earlier than 2017-06-02 | C1 | 2176h | 2176h | SAES6-CSFB | 39 | Interdigital, Aghili, Behrouz | Rel-15 | 76 | Behrouz.aghili@interdigital.com |  |  |
| 685 | 325.2 | SAES6 for support for non-3GPP accesses | 272d? | 2017-06-02 A | 2018-06-18 A | 100% |  |  | start no earlier than 2017-06-02 | C1 | 2176h | 2176h | SAES6-non3GPP | 39 | Interdigital, Aghili, Behrouz | Rel-15 | 76 | Behrouz.aghili@interdigital.com |  |  |
| 686 | 325.3 | SAE Protocol Development (Stage 3) - Phase 6 | 272d? | 2017-06-02 A | 2018-06-18 A | 100% |  |  | start no earlier than 2017-06-02 | C1 | 2176h | 2176h | SAES6 | 37 |  | Rel-15 | 72 |  |  |  |
| 687 | 326 | Security Assurance Specification for eNB network product class | 322d? | 2016-09-19 A | 2017-12-12 A | 100% |  |  | finish no earlier than 2017-12-12 | S3 | 2576h | 2576h | SCAS_eNB | 37 | Marcus Wong, Huawei Technologies | Rel-15 | 73 | mwong@huawei.com |  |  |
| 688 | 327 | Security Assurance Specification for PGW network product class | 389d? | 2016-06-17 A | 2017-12-12 A | 100% |  |  | finish no earlier than 2017-12-12 | S3 | 3112h | 3112h | SCAS_PGW | 37 | Peng Jin, China Mobile | Rel-15 | 72 | pengjin@chinamobile.com |  |  |
| 689 | 328 | HPLMN Radio Access Technology deployment Optimisation in Network Selection | 76d? | 2017-03-02 A | 2017-06-15 A | 100% |  |  | finish no earlier than 2017-06-15 | S1 | 608h | 608h | HORNS | 38 | Eddy Hall, Qualcomm Incorporated | Rel-15 | 75 | edhall@qti.qualcomm.com |  |  |
| 690 | 329 | **IMS Stage-3 IETF Protocol Alignment** | 271d? | 2017-06-02 A | 2018-06-15 | 99% | 0d? | 0d |  | ct | 12976h | 11526.6h | IMSProtoc9 | 39 | Dr. Belling, Thomas, Nokia | Rel-15 | 76 | Thomas.Belling@nokia.com |  |  |
| 691 | 329.1 | CT1 aspects of IMS Stage-3 IETF Protocol Alignment | 269d? | 2017-06-02 A | 2018-06-13 A | 100% |  |  | finish no earlier than 2018-06-13 | C1 | 2152h | 2152h | IMSProtoc9 | 39 | Dr. Belling, Thomas, Nokia | Rel-15 | 76 | Thomas.Belling@nokia.com |  |  |
| 692 | 329.2 | **(IETF) CT1 aspects of IMS Stage-3 IETF Protocol Alignment** | 271d? | 2017-06-02 A | 2018-06-15 A | 100% |  |  |  | C1-IETF | 6504h | 6504h | IMSProtoc9 | 39 | Dr. Belling, Thomas, Nokia | Rel-15 | 76 | Thomas.Belling@nokia.com |  |  |
| 693 | 329.2.1 | (IETF) Content-ID header field in SIP (draft-ietf-sipcore-content-id) | 271d? | 2017-06-02 A | 2018-06-15 A | 100% |  |  | finish no earlier than 2018-06-15 | C1-IETF | 2168h | 2168h | IMSProtoc9 | 40 | Christer Holmberg | Rel-15 | 78 | christer.holmberg@ericsson.com |  |  |
| 694 | 329.2.2 | (IETF) P-Visited-Network header updated (was: draft-jesske-update-p-visited-network ) | 271d? | 2017-06-02 A | 2018-06-15 A | 100% |  |  | finish no earlier than 2018-06-15 | C1-IETF | 2168h | 2168h | IMSProtoc9 | 40 | Michael KREIPL, Deutsche Telekom | Rel-15 | 78 | michael(dot)kreipl(at)telekom(dot)de |  |  |
| 695 | 329.3 | CT3 aspects of IMS Stage-3 IETF Protocol Alignment | 269d? | 2017-06-02 A | 2018-06-13 A | 100% |  |  | finish no earlier than 2018-06-13 | C3 | 2152h | 2152h | IMSProtoc9 | 39 | Dr. Belling, Thomas, Nokia | Rel-15 | 76 | Thomas.Belling@nokia.com |  |  |
| 696 | 330 | **Lawful Interception Rel-15** | 529d? | 2017-03-02 A | 2019-03-12 | 86% | 75.15d? | 26288d |  |  | 7448h | 4710.4h | LI15 | 38 | Alex Leadbeater, BT | Rel-15 | 75 | alex.leadbeater@bt.com |  |  |
| 697 | 330.1 | Deleted - Study on R15 Lawful Interception Service | 402d? | 2017-03-02 A | 2018-09-14 A | 100% |  |  | finish no earlier than 2018-09-14 | S3LI | 3216h | 3216h | FS_15LIS | 38 | Gerry McQuaid, Vodafone | Rel-15 | 75 | Gerald.McQuaid@vodafone.com | 82 |  |
| 698 | 330.2 | Normative work on Lawful Interception Rel-15 | 529d? | 2017-03-02 A | 2019-03-12 | 75% | 132.25d? | 26288d | finish no earlier than 2019-03-12 | S3LI | 4232h | 1494.4h | LI15 | 38 | Alex Leadbeater, BT | Rel-15 | 75 | alex.leadbeater@bt.com |  |  |
| 699 | 331 | **DL interference mitigation for UMTS** | 67d? | 2017-03-15 A | 2017-06-15 A | 100% |  |  |  | R2 | 1072h | 1072h | UTRA_DL_IM | 38 | Qualcomm | Rel-15 | 75 |  |  |  |
| 700 | 331.1 | Core part: DL interference mitigation for UMTS | 67d? | 2017-03-15 A | 2017-06-15 A | 100% |  |  | finish no earlier than 2017-06-15 | R2 | 536h | 536h | UTRA_DL_IM-Core | 38 | Qualcomm | Rel-14 | 75 |  |  | RP-171135 |
| 701 | 332 | Control and monitoring of Power, Energy and Environmental (PEE) parameters in Radio Access Networks (RAN) | 204d? | 2017-06-05 A | 2018-03-15 A | 100% |  |  | finish no earlier than 2018-03-15 | S5 | 1632h | 1632h | PEE_CMON | 39 | Jean-Michel CORNILY, ORANGE | Rel-15 | 76 |  |  |  |

Notes:
- 677: 1/12/16: 0%->100 / Impacted TSs and TRs: 22.173
- 678: 1/12/16: 0%->100; 30/6/17: 24.196 added; / Impacted TSs and TRs: 22.173; 24.196
- 680: 14/9/17: 0%->40; 15/12/17: 40%->85; 20/3/18: 85%->100 / Impacted TSs and TRs: 24.259; 24.604; 24.606; 24.607; 24.608; 24.610; 24.611; 24.615; 24.616; 24.629; 24.642; 24.647; 24.654
- 681: 7/6/18: 0%->100 / Impacted TSs and TRs: 29.165
- 682: Impacted TSs and TRs: 22.101
- 683: Impacted TSs and TRs: 23.122; 24.008; 24.167; 24.229; 24.301; 24.302; 24.303; 24.304; 24.305; 24.312; 29.018; 29.118; 24.368
- 684: 14/9/17: 0%->20; 15/12/17: 20%->55; 16/3/18: 55%->80; 7/6/18: 80%->100 / Impacted TSs and TRs: 23.122; 24.008; 24.167; 24.229; 24.301; 24.302; 24.303; 24.304; 24.305; 24.312; 29.018; 29.118; 24.368
- 685: 14/9/17: 0%->20; 15/12/17: 20%->55; 16/3/18: 55%->80; 7/6/18: 80%->100 / Impacted TSs and TRs: 23.122; 24.008; 24.167; 24.229; 24.301; 24.302; 24.303; 24.304; 24.305; 24.312; 29.018; 29.118; 24.368
- 686: 14/9/17: 0%->20; 15/12/17: 20%->55; 16/3/18: 55%->80; 7/6/18: 80%->100
- 687: 6/10/16: 33.216 added; 1/12/16: 0%->5; 6/3/17: 5%->25. Moved from Rel-14.; 7/6/17: FCD:06/17->12/17; 7/6/17: 25%->75; 11/9/17: 75%->100 / Impacted TSs and TRs: TS 33.117, TR 33.926; 33.216
- 688: 28/7/16: 33.250 added; 19/9/16: 0%->10; 6/10/16: 33.216 added; 1/12/16: 10%->40. 06/03/17: moved from Rel-14.; 6/3/17: 40%->80; 7/6/17: FCD:06/17->12/17; 7/6/17: 80%->95; 11/9/17: 95%->100 / Impacted TSs and TRs: 33.250; 33.216
- 689: 7/6/17: 75%->100
- 691: 14/9/17: 0%->40; 15/12/17: 40%->60; 16/3/18: 60%->80; 7/6/18: 80%->100 / Impacted TSs and TRs: 23.218; 24.229; 24.930
- 693: 22/3/18: 0%->100
- 694: 27/6/18: 0%->100
- 695: 15/12/17: 0%->40; 7/6/18: 40%->85; 10/9/18: 85%->100 / Impacted TSs and TRs: 29.163; 29.165; 29.949
- 696: 21/12/17: WID:SP-170039->SP-170839; 16/3/18: 10%->20
- 697: 12/7/17: 0%->5; 11/9/17: 5%->10; 16/3/18: 24%->35; 7/6/18: 35%->70; 7/6/18: FCD:06/18->09/18; 10/9/18: 70%->85. 17/01/19: deleted as per Alex's e-mail 13 Nov. Was at 85%
- 698: 12/7/17: 0%->5; 15/12/17: 5%->10; 10/9/18: 17%->40; 7/12/18: FCD:12/18->03/19; 7/12/18: 40%->75
- 699: no Perf. part
- 700: no Perf. part19/6/17: Compl:0%->100%
- 701: 30/6/17: 28.306 added;; 30/6/17: 28.305 added;; 30/6/17: 28.304 added;; 11/9/17: 0%->20; 15/12/17: 20%->80; 16/3/18: 80%->100 / Impacted TSs and TRs: New TSs, TS 52.402; TS 32.405; TS 32.425; TS 32.101; TS 32.103; 28.306; 28.305; 28.304

| ID | WBS | Task | Type | Duration | Start | Finish | Complete | Remaining | Total slack | Constraint | Resources | Work | Actual work | Acronym | PCG approved | WI rapporteur name | Release | TSG approved | Impacted TSs and TRs | WI rapporteur e-mail | Status Report |
| --- | --- | --- | --- | --- | --- | --- | --- | --- | --- | --- | --- | --- | --- | --- | --- | --- | --- | --- | --- | --- | --- |
| 702 | 333 | **Simplified HS-SCCH for UMTS** |  | 198d? | 2017-03-15 A | 2017-12-15 A | 100% |  |  |  | R6 | 3176h | 3176h | UTRA_simple_HSSCCH | 39 | Ericsson | Rel-15 | 76 |  |  |  |
| 703 | 333.1 | Study on a simplified HS-SCCH for UMTS |  | 67d? | 2017-03-15 A | 2017-06-15 A | 100% |  |  | start no earlier than 2017-03-15 | R1 | 536h | 536h | FS_UTRA_simple_HSSCCH | 38 | gerardo.agni.medina.acosta@ericsson.com | Rel-15 | 75 | 25.709 | gerardo.agni.medina.acosta@ericsson.com |  |
| 704 | 333.2 | Core part: Simplified HS-SCCH for UMTS |  | 132d? | 2017-06-15 A | 2017-12-15 A | 100% |  |  | finish no earlier than 2017-12-15 | R6 | 1056h | 1056h | UTRA_simple_HSSCCH-Core | 39 | Ericsson | Rel-15 | 76 |  |  | RP-172306 |
| 705 | 334 | Charging for enhancement to Flexible Mobile Service Steering (eFMSS) |  | 139d? | 2017-06-05 A | 2017-12-14 A | 100% |  |  | finish no earlier than 2017-12-14 | S5 | 1112h | 1112h | eFMSS_CH | 39 | Long,Biao, China Telecom | Rel-15 | 76 | TS 32.251; TS 32.298; TS 32.299 | longb.gd@chinatelecom.cn. |  |
| 706 | 335 | Receive acoustic output test in the presence of background noise |  | 131d? | 2017-12-15 A | 2018-06-15 A | 100% |  |  | finish no earlier than 2018-06-15 | S4 | 1048h | 1048h | RAOT | 40 | ISBERG, Peter, Sony Mobile Communications | Rel-15 | 78 | 26.131; 26.132 | peter.isberg [at] sony.com |  |
| 707 | 336 | Speech quality in the presence of ambient noise for super-wideband and fullband modes |  | 196d? | 2017-12-15 A | 2018-09-14 A | 100% |  |  | finish no earlier than 2018-09-14 | S4 | 1568h | 1568h | SPAN | 40 | Reimes, Jan – HEAD acoustics GmbH | Rel-15 | 78 | 26.131 | jan.reimes@head-acoustics.de |  |
| 708 | 337 | **REST Solution Sets** |  | 5223d? | 2016-09-19 A | 2036-09-24 | 3% | 5044.98d? | 21712d |  |  | 121720h | 4148.8h | REST_SS | 41 |  | Rel-15 | 78 |  |  |  |
| 709 | 337.1 | Study on a RESTful HTTP-based Solution Set |  | 322d? | 2016-09-19 A | 2017-12-12 A | 100% |  |  | finish no earlier than 2017-12-12 | S5 | 2576h | 2576h | FS_OAM_RESTFUL | 37 | Nokia: Pollakowski, Olaf | Rel-15 | 73 | 32.866 | olaf.pollakowski@nokia.com |  |
| 710 | 337.2 | REST Solution Sets (normative work) |  | 196d? | 2017-12-15 A | 2018-09-14 A | 100% |  |  | finish no earlier than 2018-09-14 | S5 | 1568h | 1568h | REST_SS | 40 | Pollakowski, Olaf, Nokia | Rel-15 | 78 | 32.101 | olaf.pollakowski@nokia.com |  |
| 711 | 337.3 | (IETF) JSON Schema: A Media Type for Describing JSON Documents (draft-handrews-json-schema) |  | 4899d? | 2017-12-15 A | 2036-09-24 |  | 4898.8d? | 21712d | finish no earlier than 2018-09-14 | S5-IETF | 39192h | 1.6h | REST_SS | 41 | Pollakowski, Olaf, Nokia | Rel-15 | 80 |  | olaf.pollakowski@nokia.com |  |
| 712 | 337.4 | (IETF) JSON Schema Validation: A Vocabulary for Structural Validation of JSON (draft-handrews-json-schema-validation) |  | 4899d? | 2017-12-15 A | 2036-09-24 |  | 4898.8d? | 21712d | finish no earlier than 2018-09-14 | S5-IETF | 39192h | 1.6h | REST_SS | 41 | Pollakowski, Olaf, Nokia | Rel-15 | 80 |  | olaf.pollakowski@nokia.com |  |
| 713 | 337.5 | (IETF) JSON Hyper-Schema: A Vocabulary for Hypermedia Annotation of JSON (draft-handrews-json-schema-hyperschema) |  | 4899d? | 2017-12-15 A | 2036-09-24 |  | 4898.8d? | 21712d | finish no earlier than 2018-09-14 | S5-IETF | 39192h | 1.6h | REST_SS | 41 | Pollakowski, Olaf, Nokia | Rel-15 | 80 |  | olaf.pollakowski@nokia.com |  |
| 714 | 338 | **Enhancements to Call spoofing functionality** |  | 132d? | 2018-03-15 A | 2018-09-14 | 75% | 33.33d? | 26415d |  | C1 | 2648h | 1278h | eSPECTRE | 41 | Axell, Jörgen, Ericsson | Rel-15 | 79 |  | Jorgen.Axell@ericsson.com |  |
| 715 | 338.1 | CT1 aspects of eSPECTRE |  | 66d? | 2018-03-15 A | 2018-06-14 A | 100% |  |  | start no earlier than 2018-03-15 | C1 | 528h | 528h | eSPECTRE |  | Axell, Jörgen, Ericsson | Rel-15 | 79 | 24.229 | Jorgen.Axell@ericsson.com |  |
| 716 | 338.2 | (IETF) PASSporT SHAKEN Extension (draft-ietf-stir-passport-shaken) |  | 67d? | 2018-06-14 A | 2018-09-14 | 25% | 50.25d? | 26415d | start no earlier than 2018-06-14 | C1-IETF | 536h | 134h | eSPECTRE |  | Axell, Jörgen, Ericsson | Rel-15 |  |  |  |  |
| 717 | 338.3 | CT3 aspects of eSPECTRE |  | 66d? | 2018-03-15 A | 2018-06-14 A | 100% |  |  | start no earlier than 2018-03-15 | C3 | 528h | 528h | eSPECTRE |  | Axell, Jörgen, Ericsson | Rel-15 | 79 | 29.163; 29.165 | Jorgen.Axell@ericsson.com |  |
| 718 | 339 | **(Small) Technical Enhancements and Improvements for Rel-15** |  | 326d? | 2017-03-17 A | 2018-06-15 | 25% | 244.5d? | 26480d |  |  | 2608h | 652h | TEI15 | 35 |  | Rel-15 | 68 |  |  |  |
| 719 | 339.1 | (IETF) The Transport Layer Security (TLS) Protocol Version 1.3 (draft-ietf-tls-tls13) |  | 326d? | 2017-03-17 A | 2018-06-15 | 25% | 244.5d? | 26480d | finish no earlier than 2018-06-15 | S3-IETF | 2608h | 652h | TEI15 | 41 |  | Rel-15 | 80 |  |  |  |
| 720 | 340 | (Small) Test Technical Enhancements and Improvements for Rel-15 |  | 196d? | 2017-03-17 A | 2017-12-15 A | 100% |  |  | finish no earlier than 2017-12-15 |  |  |  | TEI15_Test | 38 |  | Rel-15 | 75 |  |  |  |
| 721 | 341 | Release 15 Features on LTE improvements | milestone | 0d? | 2000-01-01 A | 2000-01-01 A | 100% |  |  |  |  |  |  |  |  |  | Rel-15 |  |  |  |  |
| 722 | 342 | **UL data compression in LTE** |  | 5029d? | 2000-01-03 A | 2019-03-15 | 95% | 241.82d? | 26285d |  | R2 | 80992h | 76562.7h | LTE_UDC | 39 | CATT | Rel-15 | 77 |  |  |  |
| 723 | 342.1 | Core part: UL data compression in LTE |  | 4899d? | 2000-01-03 A | 2018-09-14 | 99% | 48.99d? | 26415d | finish no earlier than 2018-09-15 | R2 | 39192h | 38800.1h | LTE_UDC-Core | 39 | CATT | Rel-15 | 77 |  |  | RP-180912 |
| 724 | 342.2 | UE Conformance Test Aspects - UL Data Compression in LTE |  | 196d? | 2018-06-15 | 2019-03-15 |  |  | 26285d | finish no earlier than 2019-03-15 | R5 | 1568h |  | LTE_UDC-UEConTest | 41 | CATT | Rel-15 | 80 |  |  |  |
| 725 | 343 | **LTE Advanced inter-band CA (4DL/4UL) of Band 41C and Band 42C** |  | 130d? | 2017-09-15 A | 2018-03-15 A | 100% |  |  |  | R4 | 3120h | 3120h | LTE_CA_4DL4UL_B41_B41_B42_B42 | 39 | KDDI | Rel-15 | 77 |  |  |  |
| 726 | 343.1 | Core part:LTE Advanced inter-band CA (4DL/4UL) of Band 41C and Band 42C |  | 130d? | 2017-09-15 A | 2018-03-15 A | 100% |  |  | finish no earlier than 2018-06-15 | R4 | 1040h | 1040h | LTE_CA_4DL4UL_B41_B41_B42_B42-Core | 39 | KDDI | Rel-15 | 77 | 36.715-04 |  |  |
| 727 | 343.2 | Perf. part:LTE Advanced inter-band CA (4DL/4UL) of Band 41C and Band 42C |  | 130d? | 2017-09-15 A | 2018-03-15 A | 100% |  |  | finish no earlier than 2018-06-15 | R4 | 1040h | 1040h | LTE_CA_4DL4UL_B41_B41_B42_B42-Perf | 39 | KDDI | Rel-15 | 77 |  |  |  |

Notes:
- 703: 19/6/17: Compl:0%->100%; 30/6/17: 25.709 added;
- 704: 11/9/17: 0%->85; 15/12/17: 85%->100; 8/1/18: WID: RP-171443->RP-172720;
- 705: 11/9/17: 0%->70; 15/12/17: 70%->100
- 706: 16/3/18: 0%->80; 16/3/18: FCD:03/18->06/18; 7/6/18: 80%->100
- 707: 16/3/18: 0%->50; 7/6/18: 50%->80; 7/6/18: FCD:06/18->09/18; 10/9/18: 80%->100
- 709: 6/10/16: 32.866 added; 1/12/16: 0%->5; 7/6/17: 5%->45; 7/6/17: FCD:06/17->12/17; 11/9/17: 45%->80; 15/12/17: 80%->100
- 710: 16/3/18: 0%->20; 7/6/18: 20%->70; 7/6/18: FCD:06/18->09/18; 10/9/18: 70%->100
- 715: 16/3/18: 0%->5; 7/6/18: 5%->50; 10/9/18: 50%->100
- 717: 10/9/18: 0%->100
- 720: Created upon demand of RAN5
- 721: -
- 723: ; 8/1/18: Compl:0%->70%; 8/1/18: CD:Mon 03/01/00->Thu 15/03/18; 27/3/18: Compl:70%->99%27/3/1 ; 27/6/18: CD:Fri 15/06/18->Sat 15/09/18;
- 724: tested: REL-15 WI LTE_UDC-Core
- 726: 15/12/17: 36.715-04 added;; 8/1/18: Compl:0%->80%27/3/18: Compl:80%->100%;
- 727: ; 27/3/18: Compl:0%->100%;

| ID | WBS | Task | Type | Duration | Start | Finish | Complete | Remaining | Total slack | Constraint | Resources | Work | Actual work | Acronym | PCG approved | WI rapporteur name | Release | TSG approved | Impacted TSs and TRs | WI rapporteur e-mail | Status Report |
| --- | --- | --- | --- | --- | --- | --- | --- | --- | --- | --- | --- | --- | --- | --- | --- | --- | --- | --- | --- | --- | --- |
| 728 | 344 | **Additional LTE bands for UE category M1 and/or NB1 in Rel-15** |  | 196d? | 2017-09-15 A | 2018-06-15 A | 100% |  |  |  | R4 | 5752h | 5752h | LTE_bands_R15_M1_NB1 | 39 | Ericsson | Rel-15 | 77 |  |  |  |
| 729 | 344.1 | Core part: Additional LTE bands for UE category M1 and/or NB1 in Rel-15 |  | 196d? | 2017-09-15 A | 2018-06-15 A | 100% |  |  | finish no earlier than 2018-06-15 | R4 | 1568h | 1568h | LTE_bands_R15_M1_NB1-Core | 39 | Ericsson | Rel-15 | 77 |  |  |  |
| 730 | 344.2 | Perf. part: Additional LTE bands for UE category M1 and/or NB1 in Rel-15 |  | 196d? | 2017-09-15 A | 2018-06-15 A | 100% |  |  | finish no earlier than 2018-06-15 | R4 | 1568h | 1568h | LTE_bands_R15_M1_NB1-Perf | 39 | Ericsson | Rel-15 | 77 |  |  |  |
| 731 | 344.3 | UE Conformance Test aspects - LTE bands with UE category M1 and/or NB1 in Rel-15 |  | 131d? | 2017-12-15 A | 2018-06-15 A | 100% |  |  | finish no earlier than 2018-06-15 | R5 | 1048h | 1048h | LTE_bands_R15_M1_NB1-UEConTest | 40 | Ericsson | Rel-15 | 78 |  |  |  |
| 732 | 345 | **Additional LTE bands for UE category M2 and/or NB2 in Rel-15** |  | 326d? | 2017-09-15 A | 2018-12-14 | 54% | 148.95d? | 26350d |  | R4 | 6264h | 3051.08h | LTE_bands_R15_M2_NB2 | 39 | Ericsson | Rel-15 | 77 |  |  |  |
| 733 | 345.1 | Core part: Additional LTE bands for UE category M2 and/or NB2 in Rel-15 |  | 196d? | 2017-09-15 A | 2018-06-15 A | 100% |  |  | finish no earlier than 2018-06-15 | R4 | 1568h | 1568h | LTE_bands_R15_M2_NB2-Core | 39 | Ericsson | Rel-15 | 77 |  |  |  |
| 734 | 345.2 | UE Conformance Test aspects - LTE bands with UE category M2 and/or NB2 in Rel-15 |  | 261d? | 2017-12-15 A | 2018-12-14 | 20% | 208.8d? | 26350d | finish no earlier than 2018-12-15 | R5 | 2088h | 417.6h | LTE_bands_R15_M2_NB2-UEConTest | 40 | Ericsson | Rel-15 | 78 |  |  |  |
| 735 | 346 | **Extended-Band12 new E-UTRA Band** |  | 130d? | 2017-09-15 A | 2018-03-15 A | 100% |  |  |  | R4 | 3120h | 3120h | Ext_B12_LTE | 39 | Ericsson | Rel-15 | 77 |  |  |  |
| 736 | 346.1 | Core part: Extended-Band12 new E-UTRA Band |  | 130d? | 2017-09-15 A | 2018-03-15 A | 100% |  |  | finish no earlier than 2018-03-15 | R4 | 1040h | 1040h | Ext_B12_LTE-Core | 39 | Ericsson | Rel-15 | 77 | 37.761 |  |  |
| 737 | 346.2 | Perf. part: Extended-Band12 new E-UTRA Band |  | 130d? | 2017-09-15 A | 2018-03-15 A | 100% |  |  | finish no earlier than 2018-03-15 | R4 | 1040h | 1040h | Ext_B12_LTE-Perf | 39 | Ericsson | Rel-15 | 77 |  |  |  |
| 738 | 347 | **Stopped - Signalling reduction to enable light connection for LTE** |  | 524d? | 2016-03-15 A | 2018-03-15 A | 100% |  |  |  |  | 7120h | 7120h | LTE_LIGHT_CON | 36 | Huawei | Rel-15 | 71 |  |  |  |
| 739 | 347.1 | Stopped - Core part: Signalling reduction to enable light connection for LTE |  | 524d? | 2016-03-15 A | 2018-03-15 A | 100% |  |  | finish no earlier than 2018-03-15 | R2 | 4192h | 4192h | LTE_LIGHT_CON-Core | 36 | Huawei | Rel-15 | 71 |  |  |  |
| 740 | 347.2 | Stopped - Study on Stage 2 of LTE_LIGHT_CON |  | 70d? | 2017-03-10 A | 2017-06-15 A | 100% |  |  | finish no earlier than 2017-06-15 | S2 | 560h | 560h | FS_LTE_LIGHT_CON | 38 | Sašo Stojanovski , intel | Rel-15 | 75 | 23.723 | saso.stojanovski@intel.com |  |
| 741 | 347.3 | **Stopped - Stage 3 of LTE_LIGHT_CON** |  | 74d? | 2016-12-01 A | 2017-03-14 A | 100% |  |  |  | ct | 2368h | 2368h | LTE_LIGHT_CON-CT | 38 | Herrero Veron, Christian (Huawei) | Rel-15 | 74 |  | Christian.Herrero at huawei.com |  |
| 742 | 347.3.1 | Stopped - CT1 aspects of LTE_LIGHT_CON |  | 74d? | 2016-12-01 A | 2017-03-14 A | 100% |  |  | finish no earlier than 2017-03-14 | C1 | 592h | 592h | LTE_LIGHT_CON-CT | 38 | Herrero Veron, Christian (Huawei) | Rel-15 | 74 | 24.008, 24.301, 29.118, 24.368, 27.007 | Christian.Herrero at huawei.com |  |
| 743 | 347.3.2 | Stopped - CT4 aspects of LTE_LIGHT_CON |  | 74d? | 2016-12-01 A | 2017-03-14 A | 100% |  |  | finish no earlier than 2017-03-14 | C4 | 592h | 592h | LTE_LIGHT_CON-CT | 38 | Herrero Veron, Christian (Huawei) | Rel-15 | 74 | 29.274, 29.272 | Christian.Herrero at huawei.com |  |
| 744 | 347.3.3 | Stopped - CT6 aspects of LTE_LIGHT_CON |  | 74d? | 2016-12-01 A | 2017-03-14 A | 100% |  |  | finish no earlier than 2017-03-14 | C6 | 592h | 592h | LTE_LIGHT_CON-CT | 38 | Herrero Veron, Christian (Huawei) | Rel-15 | 74 | 31.102 | Christian.Herrero at huawei.com |  |
| 745 | 348 | **Enhancements of Base Station (BS) RF and EMC requirements for Active Antenna System (AAS)** |  | 655d? | 2016-03-15 A | 2018-09-14 | 71% | 192.39d? | 26415d |  |  | 8920h | 6300h | AASenh_BS_LTE_UTRA | 36 | Huawei | Rel-15 | 71 | 37.843 |  |  |
| 746 | 348.1 | Core part: Enhancements of Base Station (BS) RF and EMC requirements for Active Antenna System (AAS) |  | 460d? | 2016-03-15 A | 2017-12-15 A | 100% |  |  | finish no earlier than 2017-12-15 | R4 | 3680h | 3680h | AASenh_BS_LTE_UTRA-Core | 36 | Huawei | Rel-15 | 71 |  |  | RP-172345 |
| 747 | 348.2 | Perf. part: Enhancements of Base Station (BS) RF and EMC requirements for Active Antenna System (AAS) |  | 655d? | 2016-03-15 A | 2018-09-14 | 50% | 327.5d? | 26415d | finish no earlier than 2018-09-15 | R4 | 5240h | 2620h | AASenh_BS_LTE_UTRA-Perf | 36 | Huawei | Rel-15 | 71 |  |  |  |
| 748 | 349 | **Shortened TTI and processing time for LTE** |  | 788d? | 2016-06-15 A | 2019-06-20 | 72% | 221.23d? | 26216d |  |  | 9976h | 7175.28h | LTE_sTTIandPT | 37 | Ericsson | Rel-15 | 72 |  |  |  |
| 749 | 349.1 | Core part: Shortened TTI and processing time for LTE |  | 589d? | 2016-06-15 A | 2018-09-14 | 99% | 5.89d? | 26415d | finish no earlier than 2018-09-15 | R1 | 4712h | 4664.88h | LTE_sTTIandPT-Core | 37 | Ericsson | Rel-15 | 72 |  |  | RP-181008 |
| 750 | 349.2 | Perf. part: Shortened TTI and processing time for LTE |  | 523d? | 2016-09-14 A | 2018-09-14 | 60% | 209.2d? | 26415d | finish no earlier than 2018-09-15 | R4 | 4184h | 2510.4h | LTE_sTTIandPT-Perf | 37 | Ericsson | Rel-15 | 72 |  |  |  |
| 751 | 349.3 | UE Conformance Test Aspects - Shortened TTI and processing time for LTE | manual | 135d | 2018-12-15 | 2019-06-20 |  |  |  |  | R5 | 1080h |  | LTE_sTTIandPT-UEConTest |  | Huawei | Rel-15 |  |  |  |  |

Notes:
- 729: ; 8/1/18: Compl:0%->99%27/3/18: WID: RP-172077->RP-180262; 27/6/18: Compl:99%->100%
- 730: ; 27/3/18: Compl:0%->99% ; 27/6/18: Compl:99%->100%
- 731: tested: REL-15 WI LTE_bands_R15_M1_NB1-Core27/3/ ;
- 733: ; 8/1/18: Compl:0%->99%; 27/3/18: WID: RP-172078->RP-180261; 27/6/18: Compl:99%->100%
- 734: tested: REL-15 WI LTE_bands_R15_M2_NB2-Core; 27/ ;
- 736: 15/12/17: 37.761 added;; 8/1/18: Compl:0%->25%; 27/3/18: Compl:25%->100%;
- 737: ; 8/1/18: WID: RP-172111->RP-17262527/3/18: Compl:0%->100%
- 738: no Perf. part; 14/9/17: WID:RP-160540->RP-160937; 14/9/17: WID:RP-160937->RP-171459
- 739: no Perf. part; 1/7/16: Compl:0%->10%; 1/7/16: CD:Thu 15/12/16->Wed 15/03/17; 1/7/16: WID: RP-160540->RP-16093726/9/16: Compl:10%->30%; 20/12/16: Compl:30%->75%; 20/12/16: Stat Rep: --> 21/3/17: Compl:75%->79% 21/3/17: CD:W ; 27/6
- 740: 21/3/17: 23.723 added;; 7/6/17: 0%->55. Stopped at 55%, set at 100% artificially
- 742: 6/3/17: 0%->25; 11/9/17: 25%->0
- 744: 7/3/17: 0%->100
- 745: follow-up WI of REL-13 WI AAS_BS_LTE_UTRA; 14/9/17: WID:RP-160548->RP-161668
- 746: follow-up WI of REL-13 WI AAS_BS_LTE_UTRA1/7/16: Compl:0%->5%1/7/16: CD:Fri 15/09/17->Wed 15/03/1726/9/16: Compl:5%->10% 20/12/16: Compl:10%->20%21/3/17: Compl:20%->40% ;
- 747: 1/7/16: WID: RP-160548->RP-1609401/7/16: Release: Rel-15->Rel-14; 26/9/16: WID: RP-160940->RP-161668 20/12/16: Stat Rep: -->; 21/3/17: Compl:0%->10%;
- 749: 26/9/16: Compl:0%->5%; 20/12/16: Compl:5%->10%21/3/17: Compl:10%->30%19/6/17: Compl:30%->65%19/6/17: CD: 19/9/17: Compl:65%->75%; 8/1/18: Compl:75%->99%; 8/1/18: CD:Fri 15/12/17->F ; 27/6/18: CD:Fri 15/06/1
- 750: ; 26/9/16: WID: RP-161299->RP-161922; 20/12/16: WID: RP-161922->RP-16201421/3/17: WID: RP-162014->RP-170113; 19/6/17: CD:Thu 15/03/18->Fri 15/06/1827/3/18: Compl:0%->33%; 27/6/18: Compl:33%->60%
- 751: tested: REL-15 WI LTE_sTTIandPT-Core

| ID | WBS | Task | Duration | Start | Finish | Complete | Remaining | Total slack | Constraint | Resources | Work | Actual work | Acronym | PCG approved | Impacted TSs and TRs | WI rapporteur name | Release | TSG approved | Status Report |
| --- | --- | --- | --- | --- | --- | --- | --- | --- | --- | --- | --- | --- | --- | --- | --- | --- | --- | --- | --- |
| 752 | 350 | **450MHz E-UTRA FDD Band for LTE PPDR and PMR/PAMR in Europe** | 326d? | 2016-12-15 A | 2018-03-15 A | 100% |  |  |  |  | 4192h | 4192h | LTE450_Europe_PPDR | 38 | 36.748 | Airbus | Rel-15 | 74 |  |
| 753 | 350.1 | Core part: 450MHz E-UTRA FDD Band for LTE PPDR and PMR/PAMR in Europe | 197d? | 2016-12-15 A | 2017-09-15 A | 100% |  |  | finish no earlier than 2017-09-15 | R4 | 1576h | 1576h | LTE450_Europe_PPDR-Core | 38 |  | Airbus | Rel-15 | 74 |  |
| 754 | 350.2 | Perf. part: 450MHz E-UTRA FDD Band for LTE PPDR and PMR/PAMR in Europe | 197d? | 2016-12-15 A | 2017-09-15 A | 100% |  |  | finish no earlier than 2017-09-15 | R4 | 1576h | 1576h | LTE450_Europe_PPDR-Perf | 38 |  | Airbus | Rel-15 | 74 |  |
| 755 | 350.3 | UE Conformance Test Aspects - 450MHz E-UTRA FDD Band for LTE PPDR and PMR/PAMR in Europe (Band 72) | 130d? | 2017-09-15 A | 2018-03-15 A | 100% |  |  | finish no earlier than 2018-03-15 | R5 | 1040h | 1040h | LTE450_Europe_PPDR-UEConTest | 39 |  | Airbus | Rel-15 | 77 |  |
| 756 | 351 | **E-UTRA 700MHz in Europe for Broadband-PPDR (Public Protection and Disaster Relief)** | 326d? | 2016-12-15 A | 2018-03-15 | 83% | 54.06d? | 26546d |  |  | 3136h | 2616h | LTE700_Europe_PPDR | 38 |  | Airbus | Rel-15 | 74 |  |
| 757 | 351.1 | Core part: E-UTRA 700MHz in Europe for Broadband-PPDR | 197d? | 2016-12-15 A | 2017-09-15 A | 100% |  |  | finish no earlier than 2017-09-15 | R4 | 1576h | 1576h | LTE700_Europe_PPDR-Core | 38 |  | Airbus | Rel-15 | 74 |  |
| 758 | 351.2 | Perf. part: E-UTRA 700MHz in Europe for Broadband-PPDR | 65d? | 2016-12-15 | 2017-03-15 |  |  | 26807d | finish no earlier than 2017-03-15 | R4 | 520h |  | LTE700_Europe_PPDR-Perf | 38 |  | Airbus | Rel-15 | 74 |  |
| 759 | 351.3 | UE Conformance Test Aspects - E-UTRA 700MHz in Europe for Broadband-PPDR | 130d? | 2017-09-15 A | 2018-03-15 A | 100% |  |  | finish no earlier than 2018-03-15 | R5 | 1040h | 1040h | LTE700_Europe_PPDR-UEConTest | 39 |  | Airbus | Rel-15 | 77 |  |
| 760 | 352 | **FDD operating band in the L-band for LTE** | 457d? | 2016-12-15 A | 2018-09-14 | 87% | 60.73d? | 26415d |  |  | 4720h | 4092.8h | LTE_FDD_L_Band | 38 | 36.751 | NTT DOCOMO | Rel-15 | 74 |  |
| 761 | 352.1 | Core part: FDD operating band in the L-band for LTE | 197d? | 2016-12-15 A | 2017-09-15 A | 100% |  |  | finish no earlier than 2017-09-15 | R4 | 1576h | 1576h | LTE_FDD_L_Band-Core | 38 |  | NTT DOCOMO | Rel-15 | 74 |  |
| 762 | 352.2 | Perf. part: FDD operating band in the L-band for LTE | 197d? | 2016-12-15 A | 2017-09-15 A | 100% |  |  | finish no earlier than 2017-09-15 | R4 | 1576h | 1576h | LTE_FDD_L_Band-Perf | 38 |  | NTT DOCOMO | Rel-15 | 74 |  |
| 763 | 352.3 | UE Conformance Test Aspects - FDD operating band in the L-band for LTE | 196d? | 2017-12-15 A | 2018-09-14 | 60% | 78.4d? | 26415d | finish no earlier than 2018-09-15 | R5 | 1568h | 940.8h | LTE_FDD_L_band-UEConTest | 40 |  | NTT DOCOMO | Rel-15 | 78 |  |
| 764 | 353 | **LTE Extended 1.5 GHz SDL band (1427 – 1518 MHz) and LTE CA (2DL/1UL) with Band 20** | 197d? | 2016-12-15 A | 2017-09-15 A | 100% |  |  |  |  | 2624h | 2624h | LTE_SDL_1500ext | 38 | 36.934; 36.753 | Qualcomm | Rel-15 | 74 |  |
| 765 | 353.1 | Core part: LTE Extended 1.5 GHz SDL band (1427 – 1518 MHz) and LTE CA (2DL/1UL) with Band 20 | 197d? | 2016-12-15 A | 2017-09-15 A | 100% |  |  | finish no earlier than 2017-09-15 | R4 | 1576h | 1576h | LTE_SDL_1500ext-Core | 38 |  | Qualcomm | Rel-15 | 74 |  |
| 766 | 353.2 | Perf. part: LTE Extended 1.5 GHz SDL band (1427 – 1518 MHz) and LTE CA (2DL/1UL) with Band 20 | 131d? | 2017-03-17 A | 2017-09-15 A | 100% |  |  | finish no earlier than 2017-09-15 | R4 | 1048h | 1048h | LTE_SDL_1500ext-Perf | 38 |  | Qualcomm | Rel-15 | 74 |  |
| 767 | 354 | **Add UE Power Class 2 to band 41 intra-band contiguous LTE CA** | 522d? | 2016-12-15 A | 2018-12-14 | 53% | 247.48d? | 26350d |  |  | 4184h | 2200.4h | LTE_CA_C_B41_PC2 | 38 |  | Sprint | Rel-15 | 74 |  |
| 768 | 354.1 | Core part: Add UE Power Class 2 to band 41 intra-band contiguous LTE CA | 262d? | 2016-12-15 A | 2017-12-15 A | 100% |  |  | finish no earlier than 2017-12-15 | R4 | 2096h | 2096h | LTE_CA_C_B41_PC2-Core | 38 |  | Sprint | Rel-15 | 74 |  |
| 769 | 354.2 | UE Conformance Test Aspects - Add UE Power Class 2 to band 41 intra-band contiguous LTE CA | 261d? | 2017-12-15 A | 2018-12-14 | 5% | 247.95d? | 26350d | finish no earlier than 2018-12-15 | R5 | 2088h | 104.4h | LTE_CA_C_B41_PC2-UEConTest | 40 |  | Sprint | Rel-15 | 78 |  |
| 770 | 355 | **Addition of Power Class 1 UE to bands B3/B20/B28 for LTE** | 262d? | 2016-09-15 A | 2017-09-15 A | 100% |  |  |  |  | 2096h | 2096h | LTE_HPUE_B3_B20_B28 | 37 |  | Motorola Solutions | Rel-15 | 73 |  |
| 771 | 355.1 | Core part: Addition of Power Class 1 UE to bands B3/B20/B28 for LTE | 262d? | 2016-09-15 A | 2017-09-15 A | 100% |  |  | finish no earlier than 2017-09-15 | R4 | 2096h | 2096h | LTE_HPUE_B3_B20_B28-Core | 37 |  | Motorola Solutions | Rel-15 | 73 |  |
| 772 | 356 | **TDD operating band in the L-band for LTE** | 197d? | 2016-12-15 A | 2017-09-15 A | 100% |  |  |  |  | 2624h | 2624h | LTE_TDD_L_Band | 38 | 36.753 | Huawei | Rel-15 | 74 |  |
| 773 | 356.1 | Core part: TDD operating band in the L-band for LTE | 197d? | 2016-12-15 A | 2017-09-15 A | 100% |  |  | finish no earlier than 2017-09-15 | R4 | 1576h | 1576h | LTE_TDD_L_Band-Core | 38 |  | Huawei | Rel-15 | 74 |  |
| 774 | 356.2 | Perf. part: TDD operating band in the L-band for LTE | 131d? | 2017-03-17 A | 2017-09-15 A | 100% |  |  | finish no earlier than 2017-09-15 | R4 | 1048h | 1048h | LTE_TDD_L_Band-Perf | 38 |  | Huawei | Rel-15 | 74 |  |
| 775 | 357 | **Further enhancements to Coordinated Multi-Point (CoMP) Operation for LTE** | 393d? | 2017-03-15 A | 2018-09-14 | 99% | 2.14d? | 26415d |  | R1 | 8912h | 7361.02h | feCOMP_LTE | 38 |  | Intel | Rel-15 | 75 |  |
| 776 | 357.1 | Core part: Further enhancements to Coordinated Multi-Point (CoMP) Operation for LTE | 393d? | 2017-03-15 A | 2018-09-14 | 99% | 3.93d? | 26415d | finish no earlier than 2018-09-15 | R1 | 3144h | 3112.56h | feCOMP_LTE-Core | 38 |  | Intel | Rel-15 | 75 | RP-180318 |
| 777 | 357.2 | Perf. part: Further enhancements to Coordinated Multi-Point (CoMP) Operation for LTE | 328d? | 2017-03-15 A | 2018-06-15 A | 100% |  |  | finish no earlier than 2018-06-15 | R4 | 2624h | 2624h | feCOMP_LTE-Perf | 38 |  | Intel | Rel-15 | 75 |  |

Notes:
- 752: 21/3/17: 36.748 added;
- 753: 21/3/17: Compl:0%->10%; 19/6/17: Compl:10%->75%; 19/9/17: Compl:75%->100%
- 754: 19/6/17: Compl:0%->50%19/9/17: Compl:50%->100%
- 755: ; 8/1/18: Compl:0%->77%; 27/3/18: Compl:77%->100%;
- 757: 21/3/17: Compl:0%->25%; 19/6/17: Compl:25%->80%; 19/9/17: Compl:80%->100%
- 758: 21/3/17: CD:Thu 15/06/17->Wed 15/03/17
- 759: ; 8/1/18: Compl:0%->64%27/3/18: Compl:64%->100%;
- 760: 21/3/17: 36.751 added;
- 761: 21/3/17: Compl:0%->50%; 19/6/17: Compl:50%->99%; 19/9/17: Compl:99%->100%
- 762: 19/6/17: Compl:0%->99%19/6/17: CD:Thu 15/06/19/9/17: Compl:99%->100%
- 763: tested: REL-15 WI LTE_FDD_L_Band-Core27/3/18: Compl: ;
- 764: 21/3/17: 36.934 added;; 21/3/17: 36.753 added;
- 765: 21/3/17: Compl:0%->20%19/6/17: Compl:20%->50%;19/9/17: Compl:50%->100%
- 766: ; 19/6/17: CD:Thu 15/06/17->Fri 15/09/17 19/9/17: Compl:0%->100%
- 768: 21/3/17: Compl:0%->5%; 19/6/17: Compl:5%->50%; 19/9/17: Compl:50%->90%; 8/1/18: Compl:90%->100%;
- 769: tested: REL-15 WI LTE_CA_C_B41_PC2-Core; 27/3/18: Co ;
- 771: ; 20/12/16: Compl:0%->15%; 20/12/16: CD:Wed 15/03/17->Thu 15/06/1721/3/17: Compl:15%->70%19/6/17: Compl:70%->99%19/9/17: Compl:99%->100%;
- 772: 21/3/17: 36.753 added;; 14/9/17: WID:RP-162557->RP-170304
- 773: 21/3/17: Compl:0%->15%; 19/6/17: Compl:15%->70%; 19/9/17: Compl:70%->100%
- 774: 21/3/17: WID: RP-162557->RP-170304; 19/6/17: CD:Thu 15/06/17->Fri 15/09/17; 19/9/17: Compl:0%->100%
- 775: follow-up WI of REL-14 SI FS_feCOMP_LTE completed at RAN #75; 14/9/17: WID:RP-170750->RP-171031
- 776: follow-up WI of REL-14 SI FS_feCOMP_LTE completed at RAN #75; 19/6/17: Compl:0%->70%; 19/6/17: CD:Fri 15/09/ 19/9/17: Compl:70%->90%; 27/3/18: Compl:90%->99%; 27/3/18: CD:Thu 15/03/18->Fri ; 27/6/18: CD:Fri
- 777: follow-up WI of REL-14 SI FS_feCOMP_LTE completed at RAN #7519/6/17: WID: RP-170750->RP-171031; 8/1/18: Compl:0%->65%; 8/1/18: CD:Thu 15/03/18->Fri 15/06/1827/3/18: Compl:65%->80%27/3/ ; 27/6/18: Compl:80%->100%

| ID | WBS | Task | Type | Duration | Start | Finish | Complete | Remaining | Total slack | Constraint | Resources | Work | Actual work | Acronym | PCG approved | WI rapporteur name | Release | TSG approved | Status Report |
| --- | --- | --- | --- | --- | --- | --- | --- | --- | --- | --- | --- | --- | --- | --- | --- | --- | --- | --- | --- |
| 778 | 358 | **UE Positioning Accuracy Enhancements for LTE** |  | 393d? | 2017-03-15 A | 2018-09-14 | 99% | 2.14d? | 26415d |  | R2 | 8912h | 7429.09h | LCS_LTE_acc_enh | 38 | Nokia | Rel-15 | 75 |  |
| 779 | 358.1 | Core part: UE Positioning Accuracy Enhancements for LTE |  | 393d? | 2017-03-15 A | 2018-09-14 | 99% | 3.93d? | 26415d | finish no earlier than 2018-09-15 | R2 | 3144h | 3112.56h | LCS_LTE_acc_enh-Core | 38 | Nokia | Rel-15 | 75 | RP-180947 |
| 780 | 358.2 | Perf. part: UE Positioning Accuracy Enhancements for LTE |  | 328d? | 2017-03-15 A | 2018-06-15 A | 100% |  |  | finish no earlier than 2018-06-15 | R4 | 2624h | 2624h | LCS_LTE_acc_enh-Perf | 38 | Nokia | Rel-15 | 75 |  |
| 781 | 359 | **Enhancements for high capacity stationary wireless link and introduction of 1024 QAM for LTE DL** |  | 588d? | 2016-09-14 A | 2018-12-14 | 99% | 2.36d? | 26350d |  | R1 | 11512h | 8083.2h | LTE_1024QAM_DL | 38 | Huawei | Rel-15 | 75 |  |
| 782 | 359.1 | Core part: Enhancements for high capacity stationary wireless link and introduction of 1024 QAM for LTE DL |  | 393d? | 2017-03-15 A | 2018-09-14 | 99% | 3.93d? | 26415d | finish no earlier than 2018-09-15 | R1 | 3144h | 3112.56h | LTE_1024QAM_DL-Core | 38 | Huawei | Rel-15 | 75 | RP-180854 |
| 783 | 359.2 | Perf. part: Enhancements for high capacity stationary wireless link and introduction of 1024 QAM for LTE DL |  | 588d? | 2016-09-14 A | 2018-12-14 A | 100% |  |  | finish no earlier than 2018-12-15 | R4 | 4704h | 4704h | LTE_1024QAM_DL-Perf | 38 | Huawei | Rel-15 | 75 |  |
| 784 | 360 | **Enhancements to LTE operation in unlicensed spectrum** |  | 458d? | 2017-03-15 A | 2018-12-15 | 99% | 2.75d? | 26350d |  | R1 | 8904h | 5314.36h | LTE_unlic | 38 | Nokia | Rel-15 | 75 |  |
| 785 | 360.1 | Core part: Enhancements to LTE operation in unlicensed spectrum |  | 393d? | 2017-03-15 A | 2018-09-14 | 99% | 3.93d? | 26415d | finish no earlier than 2018-09-15 | R1 | 3144h | 3112.56h | LTE_unlic-Core | 38 | Nokia | Rel-15 | 75 | RP-180948 |
| 786 | 360.2 | Perf. part: Enhancements to LTE operation in unlicensed spectrum |  | 262d? | 2017-12-14 A | 2018-12-15 A | 100% |  |  | finish no earlier than 2018-12-15 | R4 | 2096h | 2096h | LTE_unlic-Perf | 38 | Nokia | Rel-15 | 75 |  |
| 787 | 361 | **Further video enhancements for LTE** |  | 393d? | 2017-03-15 A | 2018-09-14 | 99% | 3.93d? | 26415d |  | R2 | 6288h | 6225.12h | LTE_ViLTE_enh2 | 38 | CMCC | Rel-15 | 75 |  |
| 788 | 361.1 | Core part: Further video enhancements for LTE |  | 393d? | 2017-03-15 A | 2018-09-14 | 99% | 3.93d? | 26415d | finish no earlier than 2018-09-15 | R2 | 3144h | 3112.56h | LTE_ViLTE_enh2-Core | 38 | CMCC | Rel-15 | 75 | RP-172381 |
| 789 | 362 | **Quality of Experience (QoE) Measurement Collection for streaming services in E-UTRAN** |  | 458d? | 2017-03-15 A | 2018-12-14 | 68% | 148.33d? | 26350d |  | R2 | 8384h | 5789.19h | LTE_QMC_Streaming | 38 | China Unicom | Rel-15 | 75 |  |
| 790 | 362.1 | Core part:Quality of Experience (QoE) Measurement Collection for streaming services in E-UTRAN |  | 393d? | 2017-03-15 A | 2018-09-14 | 99% | 3.93d? | 26415d | finish no earlier than 2018-09-15 | R2 | 3144h | 3112.56h | LTE_QMC_Streaming-Core | 38 | China Unicom | Rel-15 | 75 | RP-172192 |
| 791 | 362.2 | UE Conformance Test Aspects - Quality of Experience (QoE) Measurement Collection for streaming services in E-UTRAN |  | 197d? | 2018-03-15 A | 2018-12-14 | 5% | 187.15d? | 26350d | finish no earlier than 2018-12-15 | R5 | 1576h | 78.8h | LTE_QMC_Streaming-UEConTest | 40 | China Unicom | Rel-15 | 79 |  |
| 792 | 363 | **Enhancing LTE CA Utilization** |  | 718d? | 2017-03-15 A | 2019-12-15 | 43% | 411.74d? | 26090d |  | R2 | 13608h | 3879.17h | LTE_euCA | 38 | Nokia | Rel-15 | 75 |  |
| 793 | 363.1 | Core part: Enhancing LTE CA Utilization |  | 393d? | 2017-03-15 A | 2018-09-14 | 90% | 39.3d? | 26415d | finish no earlier than 2018-09-15 | R2 | 3144h | 2829.6h | LTE_euCA-Core | 38 | Nokia | Rel-15 | 75 | RP-181069 |
| 794 | 363.2 | Perf. part: Enhancing LTE CA Utilization |  | 328d? | 2017-09-13 A | 2018-12-14 | 20% | 262.4d? | 26350d | finish no earlier than 2018-12-15 | R4 | 2624h | 524.8h | LTE_euCA-Perf | 38 | Nokia | Rel-15 | 75 |  |
| 795 | 363.3 | UE Conformance Test Aspects - Enhancing LTE CA Utilization | manual | 262d | 2018-12-15 | 2019-12-15 |  |  |  |  | R5 | 2096h |  | LTE_euCA-UEConTest |  | Nokia | Rel-15 |  |  |
| 796 | 364 | **450 MHz Band for LTE in Region 3** |  | 523d? | 2017-03-15 A | 2019-03-15 | 62% | 197.83d? | 26285d |  | R4 | 9448h | 4852.81h | LTE450_Reg3 | 38 | China Unicom | Rel-15 | 75 |  |
| 797 | 364.1 | Core part: 450 MHz Band for LTE in Region 3 |  | 198d? | 2017-03-15 A | 2017-12-15 A | 100% |  |  | finish no earlier than 2017-12-15 | R4 | 1584h | 1584h | LTE450_Reg3-Core | 38 | China Unicom | Rel-15 | 75 |  |
| 798 | 364.2 | Perf. part: 450 MHz Band for LTE in Region 3 |  | 198d? | 2017-03-15 A | 2017-12-15 A | 100% |  |  | finish no earlier than 2017-12-15 | R4 | 1584h | 1584h | LTE450_Reg3-Perf | 38 | China Unicom | Rel-15 | 75 |  |
| 799 | 364.3 | UE Conformance Test Aspects - 450 MHz Band for LTE in Region 3 |  | 262d? | 2018-03-15 A | 2019-03-15 | 5% | 248.9d? | 26285d | finish no earlier than 2019-03-15 | R5 | 2096h | 104.8h | LTE450_Reg3-UEConTest | 40 | China Unicom, Shi Yu | Rel-15 | 79 |  |
| 800 | 365 | **US 600 MHz Band for LTE** |  | 198d? | 2017-03-15 A | 2017-12-15 A | 100% |  |  |  | R4 | 4240h | 4240h | LTE600_US | 38 | Ericsson | Rel-15 | 75 |  |
| 801 | 365.1 | Core part: US 600 MHz Band for LTE |  | 133d? | 2017-03-15 A | 2017-09-15 A | 100% |  |  | finish no earlier than 2017-09-15 | R4 | 1064h | 1064h | LTE600_US-Core | 38 | Ericsson | Rel-15 | 75 |  |
| 802 | 365.2 | Perf. part: US 600 MHz Band for LTE |  | 133d? | 2017-03-15 A | 2017-09-15 A | 100% |  |  | finish no earlier than 2017-09-15 | R4 | 1064h | 1064h | LTE600_US-Perf | 38 | Ericsson | Rel-15 | 75 |  |
| 803 | 365.3 | UE Conformance Test Aspects - US 600 MHz Band for LTE (Band 71) |  | 66d? | 2017-09-15 A | 2017-12-15 A | 100% |  |  | finish no earlier than 2018-03-15 | R5 | 528h | 528h | LTE600_US-UEConTest | 39 | Dish Network | Rel-15 | 77 |  |

Notes:
- 778: 14/9/17: WID:RP-170813->RP-171508
- 779: ; 19/6/17: Compl:0%->10%; 19/6/17: CD:Fri 15/12/17->Fri 15/06/18 19/9/17: Compl:10%->20%; 8/1/18: Compl:20%->40%; 8/1/18: WID: RP-171508->RP-17231327/3/18: Compl:40%->50%; 27/6/18: Compl:50%->99%;
- 780: ; 19/6/17: WID: RP-170813->RP-171508; 8/1/18: Compl:0%->30%; 8/1/18: WID: RP-171508->RP-172313; 27/6/18: Compl:30%->100%; 27/6/18: WID: RP-17231
- 781: 14/9/17: WID:RP-170838->RP-171067
- 782: ; 19/6/17: Compl:0%->20%; 19/6/17: CD:Sat 15/12/18->Thu 15/03/18 19/6/17: FCD:03/18->06/18; 12/7/17: 36.783 added;19/9/17: Compl:20%->40%; 8/1/18: Compl:40%->85%27/3/18: Compl:85%->99% / Impacted TSs and TRs: 36.783
- 783: ; 19/6/17: CD:Sat 15/12/18->Fri 15/06/18; 19/6/17: WID: RP-170838->RP-171067 19/9/17: WID: RP-171067->RP-17173827/3/18: Compl:0%->25%; 27/6/18: Compl:25%->50%; 16/1/19: 50%->100
- 784: note: The is actually a further LAA enhancement
- 785: note: The is actually a further LAA enhancement; 19/6/17: Compl:0%->15%; 19/6/17: CD:Fri 15 19/9/17: Compl:15%->30%; 8/1/18: Compl:30%->65%; 27/3/18: Compl:65%->85% 27/3/18: 37.107 added;; / Impacted TSs and TRs: 37.107; 37.106
- 786: 19/6/17: CD:Thu 15/03/18->Sat 15/12/18; 8/1/18: WID: RP-170848->RP-17284127/3/18: WID: RP-172841->RP-180402; 16/1/19: 0%->100
- 787: no Perf. part; compare REL-14 WI LTE_VoLTE_ViLTE_enh
- 788: no Perf. part; compare REL-14 WI LTE_VoLTE_ViLTE_enh19/6/17: Compl:0%->15%19/6/17: W 19/9/17: Compl:15%->35%; 8/1/18: Compl:35%->99%; ; 27/6/18: CD:Fri 15/06/18->Sat 15/09/18
- 789: compare REL-14 WI UMTS_QMC_Streaming-Core
- 790: compare REL-14 WI UMTS_QMC_Streaming-Core; 19/6/17: Compl:0%->25%; 19/6/17: WID: RP- 19/9/17: Compl:25%->45%; 8/1/18: Compl:45%->99%; ; 27/6/18: CD:Fri 15/06/18->Sat 15/09/18
- 791: tested: REL-15 WI LTE_QMC_Streaming-Core; WI code to be used: LTE_QMC_Streaming-UEConTest;
- 793: 19/9/17: Compl:0%->22%; 8/1/18: Compl:22%->40%; 16/3/18: FCD:12/17->06/1827/3/18: Compl:40%->60%27/3/18: WID: RP-170805->RP-180561; 27/6/18: Compl:60%->90%;
- 794: 16/3/18: FCD:12/17->12/18; 27/3/18: WID: RP-170805->RP-180561; 27/6/18: Compl:0%->20%
- 795: tested: REL-15 WI LTE_euCA-Core
- 796: 14/9/17: WID:RP-170159->RP-170952
- 797: ; 19/6/17: Compl:0%->30%; 19 12/7/17: 36.759 added;; 19/9/17: Compl:30%->80%; 8/1/18: Compl:80%->100% / Impacted TSs and TRs: 36.759
- 798: ; 19/6/17: WID: RP-170159->RP-170952; 8/1/18: Compl:0%->100%
- 799: ; 27/6/18: Compl:0%->5%; / Impacted TSs and TRs: 34.121-1; 36.508; 36.521-1; 36.521-2; 36.521-3; 36.523-2; 36.523-3; 37.571-1; 36.905
- 801: ; 19/6/17: Compl:0%->95%; 19 12/7/17: 36.755 added;19/9/17: Compl:95%->100% / Impacted TSs and TRs: 36.755
- 802: ; 19/6/17: Compl:0%->95%; 19 19/9/17: Compl:95%->100%
- 803: ; 8/1/18: Compl:0%->100%;

| ID | WBS | Task | Type | Duration | Start | Finish | Complete | Remaining | Total slack | Constraint | Resources | Work | Actual work | Acronym | PCG approved | WI rapporteur name | Release | TSG approved | Impacted TSs and TRs | Status Report |
| --- | --- | --- | --- | --- | --- | --- | --- | --- | --- | --- | --- | --- | --- | --- | --- | --- | --- | --- | --- | --- |
| 804 | 366 | **LAA/eLAA for the CBRS 3.5GHz band in the United States** |  | 198d? | 2017-03-15 A | 2017-12-15 A | 100% |  |  |  | R4 | 4752h | 4752h | LTE_3550_CBRS_US_LAA | 38 | AT&T | Rel-15 | 75 |  |  |
| 805 | 366.1 | Core part: LAA/eLAA for the CBRS 3.5GHz band in the United States |  | 198d? | 2017-03-15 A | 2017-12-15 A | 100% |  |  | start no earlier than 2017-03-15 | R4 | 1584h | 1584h | LTE_3550_CBRS_US_LAA-Core | 38 | AT&T | Rel-15 | 75 | 36.790 |  |
| 806 | 366.2 | Perf. part: LAA/eLAA for the CBRS 3.5GHz band in the United States |  | 198d? | 2017-03-15 A | 2017-12-15 A | 100% |  |  | start no earlier than 2017-03-15 | R4 | 1584h | 1584h | LTE_3550_CBRS_US_LAA-Perf | 38 | AT&T | Rel-15 | 75 |  |  |
| 807 | 367 | **Introduction new band support for 4Rx antenna ports for LTE for REL-15** |  | 262d? | 2017-06-15 A | 2018-06-15 A | 100% |  |  |  | R4 | 6288h | 6288h | LTE_4Rx_AP_DL_bands_R15 | 39 | Huawei | Rel-15 | 76 |  |  |
| 808 | 367.1 | Core part: Introduction new band support for 4Rx antenna ports for LTE for REL-15 |  | 262d? | 2017-06-15 A | 2018-06-15 A | 100% |  |  | finish no earlier than 2018-06-15 | R4 | 2096h | 2096h | LTE_4Rx_AP_DL_bands_R15-Core | 39 | Huawei | Rel-15 | 76 |  |  |
| 809 | 367.2 | Perf. part: Introduction new band support for 4Rx antenna ports for LTE for REL-15 |  | 262d? | 2017-06-15 A | 2018-06-15 A | 100% |  |  | finish no earlier than 2018-06-15 | R4 | 2096h | 2096h | LTE_4Rx_AP_DL_bands_R15-Perf | 39 | Huawei | Rel-15 | 76 |  |  |
| 810 | 368 | **Addition of band 28 and 40 to LTE MTC cat.0** |  | 67d? | 2017-06-15 A | 2017-09-15 A | 100% |  |  |  | R4 | 1072h | 1072h | LC_MTC_LTE_cat0_B28_B40 | 39 | Huawei | Rel-15 | 76 |  |  |
| 811 | 368.1 | Core part: Addition of band 28 and 40 to LTE MTC cat.0 |  | 67d? | 2017-06-15 A | 2017-09-15 A | 100% |  |  | finish no earlier than 2017-09-15 | R4 | 536h | 536h | LC_MTC_LTE_cat0_B28_B40-Core | 39 | Huawei | Rel-15 | 76 |  |  |
| 812 | 369 | **LTE Advanced high power TDD UE (power class 2) for Rel-15** |  | 262d? | 2017-06-15 A | 2018-06-15 A | 100% |  |  |  | R4 | 4192h | 4192h | LTE_TDD_HPUE_R15 | 39 | Huawei | Rel-15 | 76 |  |  |
| 813 | 369.1 | Core part: LTE Advanced high power TDD UE (power class 2) for Rel-15 |  | 262d? | 2017-06-15 A | 2018-06-15 A | 100% |  |  | finish no earlier than 2018-06-15 | R4 | 2096h | 2096h | LTE_TDD_HPUE_R15-Core | 39 | Huawei | Rel-15 | 76 | 36.760 |  |
| 814 | 370 | **New LTE band for 3.3-3.4 GHz for Africa** |  | 196d? | 2017-06-15 A | 2018-03-15 A | 100% |  |  |  | R4 | 4704h | 4704h | LTE_TDD_3300_Africa | 39 | Huawei | Rel-15 | 76 |  |  |
| 815 | 370.1 | Core part: New LTE band for 3.3-3.4 GHz for Africa |  | 196d? | 2017-06-15 A | 2018-03-15 A | 100% |  |  | finish no earlier than 2018-03-15 | R4 | 1568h | 1568h | LTE_TDD_3300_Africa-Core | 39 | Huawei | Rel-15 | 76 | 36.758 |  |
| 816 | 370.2 | Perf. part: New LTE band for 3.3-3.4 GHz for Africa |  | 196d? | 2017-06-15 A | 2018-03-15 A | 100% |  |  | finish no earlier than 2018-03-15 | R4 | 1568h | 1568h | LTE_TDD_3300_Africa-Perf | 39 | Huawei | Rel-15 | 76 |  |  |
| 817 | 371 | **UE requirements for network-based CRS interference mitigation for LTE** |  | 392d? | 2017-06-15 A | 2018-12-15 | 93% | 26.74d? | 26350d |  | R4 | 8888h | 8281.66h | LTE_NW_CRS_IM | 39 | Ericsson | Rel-15 | 76 |  |  |
| 818 | 371.1 | Core part: UE requirements for network-based CRS interference mitigation for LTE |  | 327d? | 2017-06-15 A | 2018-09-14 | 85% | 49.05d? | 26415d | finish no earlier than 2018-09-15 | R4 | 2616h | 2223.6h | LTE_NW_CRS_IM-Core | 39 | Ericsson | Rel-15 | 76 |  |  |
| 819 | 371.2 | Perf. part: UE requirements for network-based CRS interference mitigation for LTE |  | 392d? | 2017-06-15 A | 2018-12-15 A | 100% |  |  | finish no earlier than 2018-12-15 | R4 | 3136h | 3136h | LTE_NW_CRS_IM-Perf | 39 | Ericsson | Rel-15 | 76 |  |  |
| 820 | 372 | **Bluetooth/WLAN measurement collection in LTE Minimization of Drive Tests (MDT)** |  | 521d? | 2017-12-15 A | 2019-12-15 | 41% | 309.19d? | 26090d |  | R2 | 7832h | 2979.26h | LTE_MDT_BT_WLAN | 40 | CMCC | Rel-15 | 78 |  |  |
| 821 | 372.1 | Core part: Bluetooth/WLAN measurement collection in LTE Minimization of Drive Tests (MDT) |  | 196d? | 2017-12-15 A | 2018-09-14 | 95% | 9.8d? | 26415d | finish no earlier than 2018-09-15 | R2 | 1568h | 1489.6h | LTE_MDT_BT_WLAN-Core | 40 | CMCC | Rel-15 | 78 |  | RP-180867 |
| 822 | 372.2 | UE Conformance Test Aspects - Bluetooth/WLAN measurement collection in LTE Minimization of Drive Tests (MDT) | manual | 262d | 2018-12-15 | 2019-12-15 |  |  |  |  | R5 | 2096h |  | LTE_MDT_BT_WLAN-UEConTest |  | CMCC | Rel-15 |  |  |  |
| 823 | 373 | **Enhanced LTE Support for Aerial Vehicles** |  | 591d? | 2017-03-15 A | 2019-06-19 | 74% | 152.18d? | 26217d |  | R2 | 8952h | 6264.69h | LTE_Aerial | 40 | Ericsson | Rel-15 | 78 |  |  |
| 824 | 373.1 | Study on enhanced LTE Support for Aerial Vehicles |  | 198d? | 2017-03-15 A | 2017-12-15 A | 100% |  |  | finish no earlier than 2017-12-15 | R2 | 1584h | 1584h | FS_LTE_Aerial | 38 | NTT DOCOMO | Rel-15 | 75 | 36.777 |  |
| 825 | 373.2 | Core part: Enhanced LTE Support for Aerial Vehicles |  | 196d? | 2017-12-15 A | 2018-09-14 | 99% | 1.96d? | 26415d | finish no earlier than 2018-09-15 | R2 | 1568h | 1552.32h | LTE_Aerial-Core | 40 | Ericsson | Rel-15 | 78 |  | RP-181045 |
| 826 | 373.3 | UE Conformance Test Aspects - Enhanced LTE Support for Aerial Vehicles | manual | 134d | 2018-12-15 | 2019-06-19 |  |  |  |  | R5 | 1072h |  | LTE_Aerial-UEConTest |  | NTT DOCOMO | Rel-15 |  |  |  |
| 827 | 374 | **Separation of CP and UP for Split Option 2 of NR** |  | 131d? | 2017-12-15 A | 2018-06-15 A | 100% |  |  |  | R3 | 2096h | 2096h | NR_CPUP_Split | 40 | Ericsson | Rel-15 | 78 |  |  |
| 828 | 374.1 | Core part: Separation of CP and UP for Split Option 2 of NR |  | 131d? | 2017-12-15 A | 2018-06-15 A | 100% |  |  | finish no earlier than 2018-06-15 | R3 | 1048h | 1048h | NR_CPUP_Split-Core | 40 | Ericsson | Rel-15 | 78 |  | RP-181149 |

Notes:
- 804: compare REL-14 WI LTE_TDD_3550_CBRS_US; related to LTE band 48, intending a new band definition; includes 2DL/2UL CA with B2 Acronym changed, was "LTE_TDD_3550_CBRS_US_LAA"
- 805: compare REL-14 WI LTE_TDD_3550_CBRS_US; related to LTE band 48, intending a new band definition; includes 2DL/2UL CA with B2;19/6/17: Com; Acronym changed, was "LTE_TDD_3550_CBRS_US_LAA-Core"; 12/7/17: 36.790 added;;
- 806: compare REL-14 WI LTE_TDD_3550_CBRS_US; related to LTE band 48, intending a new band definition; includes 2DL/2UL CA with B2; 19/6/17: C Acronym changed, was "LTE_TDD_3550_CBRS_US_LAA-Perf";
- 808: 19/9/17: Compl:0%->99%; 8/1/18: WID: RP-171131->RP-17234727/3/18: Compl:99%->90% ; 27/6/18: Compl:90%->100%
- 809: ; 8/1/18: WID: RP-171131->RP-172347; 27/3/18: WID: RP-172347->RP-180073; 27/6/18: Compl:0%->100%
- 811: 19/9/17: Compl:0%->100%
- 813: 19/9/17: Compl:0%->10%; 15/12/17: 36.760 added;; 8/1/18: Compl:10%->40%27/3/18: Compl:40%->99%; 27/6/18: Comp
- 815: 12/7/17: 36.758 added;19/9/17: Compl:0%->10%; 8/1/18: Compl:10%->70%27/3/18: Compl:70%->100%;
- 816: ; 19/9/17: WID: RP-171506->RP-171759; 27/3/18: Compl:0%->100%;
- 818: ; 19/9/17: Compl:0%->15%; 8/1/18: Compl:15%->50%27/3/18: Compl:50%->70%; 27/6/18: Compl:70%->85%
- 819: ; 27/6/18: WID: RP-171408->RP-181315; 16/1/19: 0%->100
- 820: MDT = Minimization of Drive Tests; no Perf. part; may have SA5 impact
- 821: MDT = Minimization of Drive Tests; no Perf. part; may have SA5 impact27/3/18: Compl:0%->30%2 ; 27/6/18: Compl:30%->95%
- 822: tested: REL-15 WI LTE_MDT_BT_WLAN-Core
- 823: follow-up WI of REL-15 SI FS_LTE_Aerial; no Perf. part
- 824: TR 36.7XX19/6/17: Compl:0%->15%; 30/6/17: 36.777 added;; 19/9/17: Compl:15%->30%; 8/1/18: Compl:30%->100%
- 825: follow-up WI of REL-15 SI FS_LTE_Aerial; no Perf. part; 27/3/18: Compl:0%->15%; 27/6/18: Compl:15%->99%;
- 826: tested: REL-15 WI LTE_Aerial-Core
- 827: follow-up WI of REL-15 SI FS_NR_CPUP_Split; introduction of E1 interface
- 828: follow-up WI of REL-15 SI FS_NR_CPUP_Split; introduction of E1 interface. 30/1/18: acronym updated27/3/18: Compl:0%->30%27/3/18: WID: RP-172831->RP-180326; 27/6/18: Compl:30%->100%; 27/6/18: Stat Rep: ->RP-181149

| ID | WBS | Task | Duration | Start | Finish | Complete | Remaining | Total slack | Constraint | Resources | Work | Actual work | Acronym | PCG approved | WI rapporteur name | Release | TSG approved | Status Report | Impacted TSs and TRs |
| --- | --- | --- | --- | --- | --- | --- | --- | --- | --- | --- | --- | --- | --- | --- | --- | --- | --- | --- | --- |
| 829 | 375 | **UE requirements for LTE DL 8Rx antenna ports** | 261d? | 2017-12-15 A | 2018-12-14 | 53% | 121.64d? | 26350d |  | R4 | 5224h | 2789.24h | LTE_8Rx_AP_DL | 40 | Huawei | Rel-15 | 78 |  |  |
| 830 | 375.1 | Core part: UE requirements for LTE DL 8Rx antenna ports | 131d? | 2017-12-15 A | 2018-06-15 A | 100% |  |  | finish no earlier than 2018-06-15 | R4 | 1048h | 1048h | LTE_8Rx_AP_DL-Core | 40 | Huawei | Rel-15 | 78 | RP-180959 |  |
| 831 | 375.2 | Perf. part: UE requirements for LTE DL 8Rx antenna ports | 261d? | 2017-12-15 A | 2018-12-14 | 30% | 182.7d? | 26350d | finish no earlier than 2018-12-15 | R4 | 2088h | 626.4h | LTE_8Rx_AP_DL-Perf | 40 | Huawei | Rel-15 | 78 |  |  |
| 832 | 376 | **ProSe Support for Band 72 in LTE** | 261d? | 2017-12-15 A | 2018-12-14 A | 100% |  |  |  | R4 | 2624h | 2624h | LTE450_B72_Europe_ProSe | 40 | Airbus | Rel-15 | 78 |  |  |
| 833 | 376.1 | Core part: ProSe Support for Band 72 in LTE | 1d? | 2017-12-15 A | 2017-12-15 A | 100% |  |  | finish no earlier than 2017-12-15 | R4 | 8h | 8h | LTE450_B72_Europe_ProSe-Core | 40 | Airbus | Rel-15 | 78 |  |  |
| 834 | 376.2 | UE Conformance Test Aspects - ProSe Support for Band 72 in LTE | 66d? | 2018-09-14 A | 2018-12-14 A | 100% |  |  | finish no earlier than 2018-12-14 | R5 | 528h | 528h | LTE450_B72_Europe_ProSe-UEConTest | 41 | Airbus | Rel-15 | 81 |  |  |
| 835 | 377 | **LTE Advanced inter-band CA Rel-15 for xDL/1UL with x>5** | 261d? | 2017-12-15 A | 2018-12-14 A | 100% |  |  |  | R4 | 5224h | 5224h | LTE_CA_R15_xDL1UL | 40 | Qualcomm | Rel-15 | 78 |  |  |
| 836 | 377.1 | Core part:LTE Advanced inter-band CA Rel-15 for xDL/1UL with x>5 | 131d? | 2017-12-15 A | 2018-06-15 A | 100% |  |  | finish no earlier than 2018-06-15 | R4 | 1048h | 1048h | LTE_CA_R15_xDL1UL-Core | 40 | Qualcomm | Rel-15 | 78 |  | 36.715-00-01 |
| 837 | 377.2 | Perf. part:LTE Advanced inter-band CA Rel-15 for xDL/1UL with x>5 | 261d? | 2017-12-15 A | 2018-12-14 A | 100% |  |  | finish no earlier than 2018-12-15 | R4 | 2088h | 2088h | LTE_CA_R15_xDL1UL-Perf | 40 | Qualcomm | Rel-15 | 78 |  |  |
| 838 | 378 | **Performance requirements of interference cancellation receiver for LTE BS** | 67d? | 2017-06-15 A | 2017-09-15 A | 100% |  |  |  | R4 | 1072h | 1072h | LTE_IC_BS | 39 | China Telecom | Rel-15 | 76 |  |  |
| 839 | 378.1 | Perf. part: Performance requirements of interference cancellation receiver for LTE BS | 67d? | 2017-06-15 A | 2017-09-15 A | 100% |  |  | finish no earlier than 2017-09-15 | R4 | 536h | 536h | LTE_IC_BS-Perf | 39 | China Telecom | Rel-15 | 76 |  |  |
| 840 | 379 | **LTE CRS-Interference Mitigation performance requirements for single RX chain UEs** | 262d? | 2017-06-15 A | 2018-06-15 A | 100% |  |  |  | R4 | 4192h | 4192h | LTE_1RX_CRS_IM | 39 | Intel | Rel-15 | 76 |  |  |
| 841 | 379.1 | Perf. part: LTE CRS-Interference Mitigation performance requirements for single RX chain UEs | 262d? | 2017-06-15 A | 2018-06-15 A | 100% |  |  | finish no earlier than 2018-06-15 | R4 | 2096h | 2096h | LTE_1RX_CRS_IM-Perf | 39 | Intel | Rel-15 | 76 |  |  |
| 842 | 380 | **LTE Advanced intra-band CA Rel-15 for xDL/yUL including contiguous and non-contiguous spectrum** | 262d? | 2017-06-15 A | 2018-06-15 A | 100% |  |  |  | R4 | 6288h | 6288h | LTE_CA_R15_intra | 39 | Ericsson | Rel-15 | 76 |  |  |
| 843 | 380.1 | Core part: LTE Advanced intra-band CA Rel-15 for xDL/yUL including contiguous and non-contiguous spectrum | 262d? | 2017-06-15 A | 2018-06-15 A | 100% |  |  | finish no earlier than 2018-06-15 | R4 | 2096h | 2096h | LTE_CA_R15_intra-Core | 39 | Ericsson | Rel-15 | 76 |  | 36.715-00-00 |
| 844 | 380.2 | Perf. part: LTE Advanced intra-band CA Rel-15 for xDL/yUL including contiguous and non-contiguous spectrum | 262d? | 2017-06-15 A | 2018-06-15 A | 100% |  |  | finish no earlier than 2018-06-15 | R4 | 2096h | 2096h | LTE_CA_R15_intra-Perf | 39 | Ericsson | Rel-15 | 76 |  |  |
| 845 | 381 | **LTE Advanced inter-band CA Rel-15 for 2DL/1UL** | 262d? | 2017-06-15 A | 2018-06-15 A | 100% |  |  |  | R4 | 6288h | 6288h | LTE_CA_R15_2DL1UL | 39 | Qualcomm | Rel-15 | 76 |  |  |
| 846 | 381.1 | Core part:LTE Advanced inter-band CA Rel-15 for 2DL/1UL | 262d? | 2017-06-15 A | 2018-06-15 A | 100% |  |  | finish no earlier than 2018-06-15 | R4 | 2096h | 2096h | LTE_CA_R15_2DL1UL-Core | 39 | Qualcomm | Rel-15 | 76 |  | 36.715-02-01 |
| 847 | 381.2 | Perf. part:LTE Advanced inter-band CA Rel-15 for 2DL/1UL | 262d? | 2017-06-15 A | 2018-06-15 A | 100% |  |  | finish no earlier than 2018-06-15 | R4 | 2096h | 2096h | LTE_CA_R15_2DL1UL-Perf | 39 | Qualcomm | Rel-15 | 76 |  |  |
| 848 | 382 | **LTE Advanced inter-band CA Rel-15 for 3DL/1UL** | 262d? | 2017-06-15 A | 2018-06-15 A | 100% |  |  |  | R4 | 6288h | 6288h | LTE_CA_R15_3DL1UL | 39 | Huawei | Rel-15 | 76 |  |  |
| 849 | 382.1 | Core part:LTE Advanced inter-band CA Rel-15 for 3DL/1UL | 262d? | 2017-06-15 A | 2018-06-15 A | 100% |  |  | finish no earlier than 2018-06-15 | R4 | 2096h | 2096h | LTE_CA_R15_3DL1UL-Core | 39 | Huawei | Rel-15 | 76 |  | 36.715-03-01 |
| 850 | 382.2 | Perf. part:LTE Advanced inter-band CA Rel-15 for 3DL/1UL | 262d? | 2017-06-15 A | 2018-06-15 A | 100% |  |  | finish no earlier than 2018-06-15 | R4 | 2096h | 2096h | LTE_CA_R15_3DL1UL-Perf | 39 | Huawei | Rel-15 | 76 |  |  |
| 851 | 383 | **LTE Advanced inter-band CA Rel-15 for 4DL/1UL** | 262d? | 2017-06-15 A | 2018-06-15 A | 100% |  |  |  | R4 | 6288h | 6288h | LTE_CA_R15_4DL1UL | 39 | Ericsson | Rel-15 | 76 |  |  |
| 852 | 383.1 | Core part:LTE Advanced inter-band CA Rel-15 for 4DL/1UL | 262d? | 2017-06-15 A | 2018-06-15 A | 100% |  |  | finish no earlier than 2018-06-15 | R4 | 2096h | 2096h | LTE_CA_R15_4DL1UL-Core | 39 | Ericsson | Rel-15 | 76 |  | 36.715-04-01 |
| 853 | 383.2 | Perf. part:LTE Advanced inter-band CA Rel-15 for 4DL/1UL | 262d? | 2017-06-15 A | 2018-06-15 A | 100% |  |  | finish no earlier than 2018-06-15 | R4 | 2096h | 2096h | LTE_CA_R15_4DL1UL-Perf | 39 | Ericsson | Rel-15 | 76 |  |  |

Notes:
- 829: follow-up WI of REL-15 SI FS_LTE_8Rx_AP_DL
- 830: follow-up WI of REL-15 SI FS_LTE_8Rx_AP_DL27/3/18: Compl:0%->40%; 27/6/18: Compl:40%->100%
- 831: follow-up WI of REL-15 SI FS_LTE_8Rx_AP_DL; 27/6/18: Compl:0%->30%
- 832: This WI was opened, a RAN4 CR RP-172572 was approved and the WI was completed all at RAN #78; compare REL-15 WI LTE450_Europe_PPDR-Core; 16/1/19: WID:RP-172568->RP-182441
- 833: This WI was opened, a RAN4 CR RP-172572 was approved and the WI was completed all at RAN #78; compare REL-15 WI LTE450_Europe_PPDR-Core;
- 834: 16/1/19: 0%->100
- 835: basket CA WI; TR 36.715-00-01
- 836: basket CA WI; TR 36.715-00-01; 27/3/18: Compl:0%->10%; 27/3/18: 36.715-00-01 added;; 27/6/18: Compl:10%->100%;
- 837: basket CA WI27/3/18: CD:Sat 15/12/18->Fri 15/06/18 ; 27/6/18: Compl:0%->50%;; 16/1/19: 50%->100
- 839: ; 19/9/17: Compl:0%->100%
- 841: ; 19/9/17: Compl:0%->20%; 19/9/17: WID: RP-171465->RP-171831; 8/1/18: Compl:20%->60%; 27/3/18: Compl:60%->85%; 27/6/18: Compl:85%->100%
- 843: 12/7/17: 36.715-00-00 added;; 19/9/17: Compl:0%->25% 8/1/18: Compl:25%->70%;27/3/18: Compl:70%->67%; ; 27/6/18: Compl:67%->100%;
- 844: 19/9/17: Compl:0%->25%; 8/1/18: Compl:25%->70%; 8/1/18:27/3/18: Compl:70%->67%; ; 27/6/18: Compl:67%->100%;
- 846: 12/7/17: 36.715-02-01 added;19/9/17: Compl:0%->20%; 8/1/18: Compl:20%->30%; 27/3/18: Compl:30%->40%; ; 27/6/18: Compl:40%->100%;
- 847: ; 19/9/17: Compl:0%->20% 8/1/18: Compl:20%->30%;27/3/18: Compl:30%->40% ; 27/6/18: Compl:40%->100%;
- 849: 12/7/17: 36.715-03-01 added;; 19/9/17: Compl:0%->20%; 8/1/18: Compl:20%->40%; 27/3/18: Compl:40%->65%; ; 27/6/18: Compl:65%->100%;
- 850: ; 19/9/17: Compl:0%->20%; 8/1/18: Compl:20%->40%;27/3/18: Compl:40%->65%; ; 27/6/18: Compl:65%->100%;
- 852: 12/7/17: 36.715-04-01 added;; 19/9/17: Compl:0%->54% 8/1/18: Compl:54%->65%;27/3/18: Compl:65%->63% ; 27/6/18: Compl:63%->100%;
- 853: 19/9/17: Compl:0%->54%; 8/1/18: Compl:54%->65%; 27/3/18: Compl:65%->63% ; 27/6/18: Compl:63%->100%;

| ID | WBS | Task | Type | Duration | Start | Finish | Complete | Remaining | Baseline start | Baseline finish | Baseline duration | Total slack | Constraint | Resources | Work | Actual work | Acronym | PCG approved | WI rapporteur name | Release | TSG approved | Impacted TSs and TRs | WI rapporteur e-mail | MCC resp | Acronym_3GU_Export | Status Report |
| --- | --- | --- | --- | --- | --- | --- | --- | --- | --- | --- | --- | --- | --- | --- | --- | --- | --- | --- | --- | --- | --- | --- | --- | --- | --- | --- |
| 854 | 384 | **LTE Advanced inter-band CA Rel-15 for 5DL/1UL** |  | 262d? | 2017-06-15 A | 2018-06-15 A | 100% |  |  |  |  |  |  | R4 | 6288h | 6288h | LTE_CA_R15_5DL1UL | 39 | Nokia | Rel-15 | 76 |  |  |  |  |  |
| 855 | 384.1 | Core part:LTE Advanced inter-band CA Rel-15 for 5DL/1UL |  | 262d? | 2017-06-15 A | 2018-06-15 A | 100% |  |  |  |  |  | finish no earlier than 2018-06-15 | R4 | 2096h | 2096h | LTE_CA_R15_5DL1UL-Core | 39 | Nokia | Rel-15 | 76 | 36.715-05-01 |  |  |  |  |
| 856 | 384.2 | Perf. part:LTE Advanced inter-band CA Rel-15 for 5DL/1UL |  | 262d? | 2017-06-15 A | 2018-06-15 A | 100% |  |  |  |  |  | finish no earlier than 2018-06-15 | R4 | 2096h | 2096h | LTE_CA_R15_5DL1UL-Perf | 39 | Nokia | Rel-15 | 76 |  |  |  |  |  |
| 857 | 385 | **LTE Advanced inter-band CA Rel-15 for 2DL/2UL** |  | 262d? | 2017-06-15 A | 2018-06-15 A | 100% |  |  |  |  |  |  | R4 | 6288h | 6288h | LTE_CA_R15_2DL2UL | 39 | Huawei | Rel-15 | 76 |  |  |  |  |  |
| 858 | 385.1 | Core part:LTE Advanced inter-band CA Rel-15 for 2DL/2UL |  | 262d? | 2017-06-15 A | 2018-06-15 A | 100% |  |  |  |  |  | finish no earlier than 2018-06-15 | R4 | 2096h | 2096h | LTE_CA_R15_2DL2UL-Core | 39 | Huawei | Rel-15 | 76 | 36.715-02-02 |  |  |  |  |
| 859 | 385.2 | Perf. part:LTE Advanced inter-band CA Rel-15 for 2DL/2UL |  | 262d? | 2017-06-15 A | 2018-06-15 A | 100% |  |  |  |  |  | finish no earlier than 2018-06-15 | R4 | 2096h | 2096h | LTE_CA_R15_2DL2UL-Perf | 39 | Huawei | Rel-15 | 76 |  |  |  |  |  |
| 860 | 386 | **LTE Advanced inter-band CA Rel-15 for xDL/2UL with x=3,4,5** |  | 262d? | 2017-06-15 A | 2018-06-15 A | 100% |  |  |  |  |  |  | R4 | 6288h | 6288h | LTE_CA_R15_xDL2UL | 39 | LG Electronics | Rel-15 | 76 |  |  |  |  |  |
| 861 | 386.1 | Core part:LTE Advanced inter-band CA Rel-15 for xDL/2UL with x=3,4,5 |  | 262d? | 2017-06-15 A | 2018-06-15 A | 100% |  |  |  |  |  | finish no earlier than 2018-06-15 | R4 | 2096h | 2096h | LTE_CA_R15_xDL2UL-Core | 39 | LG Electronics | Rel-15 | 76 | 36.715-00-02 |  |  |  |  |
| 862 | 386.2 | Perf. part:LTE Advanced inter-band CA Rel-15 for xDL/2UL with x=3,4,5 |  | 262d? | 2017-06-15 A | 2018-06-15 A | 100% |  |  |  |  |  | finish no earlier than 2018-06-15 | R4 | 2096h | 2096h | LTE_CA_R15_xDL2UL-Perf | 39 | LG Electronics | Rel-15 | 76 |  |  |  |  |  |
| 863 | 387 | UE Conformance Test Aspects – Rel-15 CA configurations |  | 456d? | 2017-09-15 A | 2019-06-14 | 9% | 414.96d? |  |  |  | 26220d | finish no earlier than 2019-06-15 | R5 | 3648h | 328.32h | LTE_CA_R15-UEConTest | 39 | Ericsson | Rel-15 | 77 |  |  |  |  |  |
| 864 | 388 | **LTE UE Total Radiated Power (TRP) and Total Radiated Sensitivity (TRS) and UTRA Hand Phantom related UE TRP and TRS Requirements** |  | 1315d? | 2012-12-15 A | 2017-12-15 | 82% | 237.88d? | 2013-03-15 | 2015-06-12 | 591d? | 26610d |  |  | 17816h | 14593.1h | LTE_UTRA_TRP_TRS | 30 | Nokia | Rel-15 | 58 | UTRA, LTE | petri.j.vasenkari@nokia.com | Issam | LTE_UTRA_TRP_TRS |  |
| 865 | 388.1 | Core part: LTE UE TRP and TRS and UTRA Hand Phantom related UE TRP and TRS Requirements |  | 1244d? | 2012-12-15 A | 2017-12-15 | 85% | 186.6d? | 2013-03-15 | 2014-09-12 | 393d? | 26610d | finish no earlier than 2017-12-15 | R4 | 9952h | 8459.2h | LTE_UTRA_TRP_TRS-Core | 30 | Nokia | Rel-15 | 58 | 25.144, New TS 37.144 | petri.j.vasenkari@nokia.com | Issam | LTE_UTRA_TRP_TRS-Core |  |
| 866 | 388.2 | Test part: LTE UE TRP and TRS and UTRA Hand Phantom |  | 983d? | 2014-03-15 A | 2017-12-15 | 78% | 216.26d? | 2014-03-06 | 2015-06-12 | 332d? | 26610d | finish no earlier than 2017-12-15 | R5 | 7864h | 6133.92h | LTE_UTRA_TRP_TRS-UEConTest | 32 | ZTE | Rel-15 | 63 | New TS 37.544 | TAYLOR Carolyn (carolyn.tayl@zte.com.cn) | Ingbert | LTE_UTRA_TRP_TRS-UEConTest |  |
| 867 | 389 | **Further enhancements for Extended Coverage GSM for support of Cellular Internet of Things** |  | 132d? | 2018-03-15 A | 2018-09-15 | 90% | 13.2d? |  |  |  | 26415d |  | R6 | 3168h | 2115.17h | CIoT_EC_GSM_fenh | 40 | Nokia | Rel-15 | 79 |  |  |  |  |  |
| 868 | 389.1 | Core part: Further enhancements for Extended Coverage GSM for support of Cellular Internet of Things |  | 132d? | 2018-03-15 A | 2018-09-14 | 80% | 26.4d? |  |  |  | 26415d | finish no earlier than 2018-09-15 | R6 | 1056h | 844.8h | CIoT_EC_GSM_fenh-Core | 40 | Nokia | Rel-15 | 79 |  |  |  |  |  |
| 869 | 389.2 | Perf. part: Further enhancements for Extended Coverage GSM for support of Cellular Internet of Things |  | 132d? | 2018-03-15 A | 2018-09-15 A | 100% |  |  |  |  |  | finish no earlier than 2018-09-15 | R6 | 1056h | 1056h | CIoT_EC_GSM_fenh-Perf | 40 | Nokia | Rel-15 | 79 |  |  |  |  |  |
| 870 | 390 | **LTE Advanced inter-band CA Rel-15 for xDL/3UL with x=3,4,5** |  | 67d? | 2018-03-15 A | 2018-06-15 A | 100% |  |  |  |  |  |  | R4 | 1072h | 1072h | LTE_CA_R15_xDL3UL | 40 | KDDI | Rel-15 | 79 |  |  |  |  |  |
| 871 | 390.1 | Core part: LTE Advanced inter-band CA Rel-15 for xDL/3UL with x=3,4,5 |  | 67d? | 2018-03-15 A | 2018-06-15 A | 100% |  |  |  |  |  | finish no earlier than 2018-06-15 | R4 | 536h | 536h | LTE_CA_R15_xDL3UL-Core | 40 | KDDI | Rel-15 | 79 |  |  |  |  |  |
| 872 | 390.2 | Perf. Part: LTE Advanced inter-band CA Rel-15 for xDL/3UL with x=3,4,5 | milestone | 0d? | 2018-05-15 A | 2018-06-15 A | 100% |  |  |  |  |  | finish no earlier than 2018-06-15 | R4 |  |  | LTE_CA_R15_xDL3UL-Perf | 41 | KDDI | Rel-15 | 80 |  |  |  |  |  |
| 873 | 391 | **Addition of Power Class 1 UE to bands B31/B72 for LTE** |  | 197d? | 2018-03-15 A | 2018-12-14 | 99% | 0d? |  |  |  | 0d |  | R4 | 2640h | 1592.12h | LTE_PC1_B31_B72 | 40 | Airbus | Rel-15 | 79 |  |  |  |  |  |
| 874 | 391.1 | Core part: Addition of Power Class 1 UE to bands B31/B72 for LTE |  | 67d? | 2018-03-15 A | 2018-06-15 A | 100% |  |  |  |  |  | finish no earlier than 2018-12-15 | R4 | 536h | 536h | LTE_PC1_B31_B72-Core | 40 | Airbus | Rel-15 | 79 |  |  |  |  |  |
| 875 | 391.2 | UE Conformance Test Aspects - Addition of Power Class 1 UE to bands B31/B72 for LTE |  | 66d? | 2018-09-14 A | 2018-12-14 A | 100% |  |  |  |  |  | finish no earlier than 2018-12-14 | R5 | 528h | 528h | LTE_PC1_B31_B72-UEConTest |  | Airbus | Rel-15 |  |  |  |  |  |  |
| 876 | 392 | Release 15 Studies | milestone | 0d? | 2016-06-09 A | 2016-06-09 A | 100% |  |  |  |  |  | finish no earlier than 2016-06-09 |  |  |  |  |  |  | Rel-15 |  |  |  |  |  |  |
| 877 | 393 | Release 15 Studies on 5G | milestone | 0d? | 2016-06-09 A | 2016-06-09 A | 100% |  |  |  |  |  | finish no earlier than 2016-06-09 |  |  |  |  |  |  | Rel-15 |  |  |  |  |  |  |
| 878 | 394 | Study on management aspects of virtualized network functions that are part of the NR |  | 325d? | 2016-09-19 A | 2017-12-15 A | 100% |  |  |  |  |  | finish no earlier than 2017-12-15 | S5 | 2600h | 2600h | FS_MA_RNVNF | 37 | Intel (Joey Chou | Rel-15 | 73 | TR 32.864 | joey.chou@intel.com |  |  |  |
| 879 | 395 | Study on CU-DU lower layer split for New Radio |  | 328d? | 2017-03-15 A | 2018-06-15 A | 100% |  |  |  |  |  | finish no earlier than 2018-06-15 | R3 | 2624h | 2624h | FS_NR_CU_DU_LLS | 38 | NTT DOCOMO | Rel-15 | 75 | 38.816 |  |  |  |  |
| 880 | 396 | Study on NR to support non-terrestrial networks |  | 328d? | 2017-03-15 A | 2018-06-15 A | 100% |  |  |  |  |  | finish no earlier than 2018-06-15 | R1 | 2624h | 2624h | FS_NR_nonterr_nw | 38 | Thales | Rel-15 | 75 | 38.811 |  |  |  |  |
| 881 | 397 | STOPPED AT SA#77 - SA3 aspects on Study on Architecture and Security for Next Generation System |  | 467d? | 2016-03-01 A | 2017-12-12 A | 100% |  |  |  |  |  | finish no earlier than 2017-12-12 | S3 | 3736h | 3736h | FS_NSA | 36 | Vesa Torvinen, Ericsson | Rel-15 | 71 | TR 33.899 | vesa.torvinen@ericsson.com |  |  |  |
| 882 | 398 | Study on separation of CP and UP for split option 2 of NR |  | 132d? | 2017-06-15 A | 2017-12-15 A | 100% |  |  |  |  |  | finish no earlier than 2017-12-15 | R3 | 1056h | 1056h | FS_NR_CPUP_Split | 39 | Ericsson | Rel-15 | 76 | 38.806 |  |  |  |  |
| 883 | 399 | Release 15 Studies on 4G/LTE | milestone | 0d? | 2016-06-09 A | 2016-06-09 A | 100% |  |  |  |  |  | finish no earlier than 2016-06-09 |  |  |  |  |  |  | Rel-15 |  |  |  |  |  |  |
| 884 | 400 | Stopped - Study on LTE bandwidth flexibility enhancements |  | 263d? | 2016-03-15 A | 2017-03-15 A | 100% |  |  |  |  |  | finish no earlier than 2017-03-15 | R4 | 2104h | 2104h | FS_LTE_BW_flex | 36 | Huawei | Rel-15 | 71 | 36.740 |  |  |  |  |
| 885 | 401 | Study on interference cancellation receiver for LTE BS |  | 196d? | 2016-09-15 A | 2017-06-15 A | 100% |  |  |  |  |  | finish no earlier than 2017-06-15 | R4 | 1568h | 1568h | FS_LTE_IC_BS | 37 | China Telecom | Rel-15 | 73 | 36.766 |  |  |  |  |
| 886 | 402 | Study on uplink data compression in LTE |  | 197d? | 2016-12-15 A | 2017-09-15 A | 100% |  |  |  |  |  | finish no earlier than 2017-09-15 | R2 | 1576h | 1576h | FS_LTE_UDC | 38 | CATT | Rel-15 | 74 | 36.754 |  |  |  |  |
| 887 | 403 | Study on LTE DL 8Rx antenna ports |  | 132d? | 2017-06-15 A | 2017-12-15 A | 100% |  |  |  |  |  | finish no earlier than 2017-12-15 | R4 | 1056h | 1056h | FS_LTE_8Rx_AP_DL | 39 | Huawei | Rel-15 | 76 | 36.757 |  |  |  |  |
| 888 | 404 | Other Release 15 Studies |  | 136d? | 2017-09-08 A | 2018-03-16 A | 100% |  |  |  |  |  | finish no earlier than 2018-03-16 |  |  |  |  |  |  | Rel-15 |  |  |  |  |  |  |
| 889 | 405 | Study on Update to fixed-point basic operators |  | 135d? | 2017-09-08 A | 2018-03-15 A | 100% |  |  |  |  |  | finish no earlier than 2018-03-15 | S4 | 1080h | 1080h | FS_BASOP | 39 | Jelinek, Milan, VoiceAge Corporation | Rel-15 | 77 | New; 26.973 | Milan.Jelinek@USherbrooke.ca |  |  |  |
| 890 | 406 | Study on further enhancements to LTE Device to Device (D2D), UE to network relays for IoT (Internet of Things) and wearables |  | 460d? | 2016-03-15 A | 2017-12-15 A | 100% |  |  |  |  |  | finish no earlier than 2017-12-15 | R2 | 3680h | 3680h | FS_feD2D_IoT_relay_wearable | 36 | Qualcomm | Rel-15 | 71 | 36.746 |  |  |  |  |
| 891 | 407 | Study on Energy Efficiency Aspects of 3GPP Standards |  | 327d? | 2016-03-11 A | 2017-06-09 A | 100% |  |  |  |  |  | finish no earlier than 2017-06-09 | SP | 2616h | 2616h | FS_ENEFF | 36 | Orange, Xiaobao Chen | Rel-15 | 71 | TR 21.866 | xiaobao.chen@orange.com |  |  | _SP-170533 |
| 892 | 408 | Study on OAM support for assessment of energy efficiency in mobile access networks |  | 421d? | 2015-11-02 A | 2017-06-09 A | 100% |  |  |  |  |  | finish no earlier than 2017-06-09 | S5 | 3368h | 3368h | FS_OAM_EE | 36 | Cornily,Jean-Michel, ORANGE | Rel-15 | 70 | TR 32.856 | jeanmichel.cornily@orange.com |  |  |  |
| 893 | 409 | Study on evaluation methodology of new V2X use cases for LTE and NR |  | 328d? | 2017-03-15 A | 2018-06-15 A | 100% |  |  |  |  |  | finish no earlier than 2018-06-15 | R1 | 2624h | 2624h | FS_LTE_NR_V2X_eval | 38 | LG Electronics | Rel-15 | 75 | 37.885 |  |  |  |  |
| 894 | 410 | Study on FEC for MC Services |  | 204d? | 2017-06-05 A | 2018-03-15 A | 100% |  |  |  |  |  | finish no earlier than 2018-03-15 | S4 | 1632h | 1632h | FS_FEC_MCS | 39 | Lambrou, John - Motorola Solutions | Rel-15 | 76 | 26.881 | john (dot) lambrou (at) motorolasolutions (dot) com |  |  |  |
| 895 | 411 | Study on Enhanced Isolated E-UTRAN Operation for Public Safety |  | 205d? | 2016-03-07 A | 2016-12-15 A | 100% |  |  |  |  |  | finish no earlier than 2016-12-15 | S2 | 1640h | 1640h | FS_IOPS_LB | 36 | Antoine Mouquet, Orange | Rel-15 | 71 | 23.798 | antoine.mouquet@orange.com |  |  |  |
| 896 | 412 | Study on Management Enhancement of CUPS of EPC Nodes |  | 269d? | 2016-12-01 A | 2017-12-12 A | 100% |  |  |  |  |  | finish no earlier than 2017-12-12 | S5 | 2152h | 2152h | FS_MECUPS | 38 | Huawei; Jiang, Junyi | Rel-15 | 74 | 32.867 | jiangjunyi@huawei.com |  |  |  |
| 897 | 413 | Study on Technical Requirements for a new secure platform for 3GPP applications |  | 328d? | 2016-06-13 A | 2017-09-12 A | 100% |  |  |  |  |  | finish no earlier than 2017-09-12 | C6 | 2624h | 2624h | FS_NG_SP | 37 | Heiko Kruse | Rel-15 | 72 | TR 31.801 | heiko.kruse@safrangroup.com |  |  |  |
| 898 | 414 | Study on technical requirements for a new secure platform for 3GPP applications |  | 140d? | 2017-03-03 A | 2017-09-14 A | 100% |  |  |  |  |  | finish no earlier than 2017-09-14 | C6 | 1120h | 1120h | FS_NG_SP2 | 38 | Heiko Kruse | Rel-15 | 75 | 31.801 | heiko.kruse@safrangroup.com |  |  |  |
| 899 | 415 | Study on scheduling enhancements with CA for UMTS |  | 67d? | 2017-03-15 A | 2017-06-15 A | 100% |  |  |  |  |  | finish no earlier than 2017-06-15 | R1 | 536h | 536h | FS_UTRA_CA_sched_enh | 38 | Huawei | Rel-15 | 75 | 25.708 |  |  |  |  |
| 900 | 416 | Study on Architecture Evolution for E-UTRAN |  | 262d? | 2017-03-15 A | 2018-03-15 A | 100% |  |  |  |  |  | finish no earlier than 2018-03-15 | R3 | 2096h | 2096h | FS_LTE_arch_evo | 38 | China Unicom | Rel-15 | 75 | 36.756; 37.876 |  |  |  |  |
| 901 | 417 | Study on Enhanced Acoustic Test Specifications |  | 1246d? | 2013-03-18 A | 2017-12-12 A | 100% |  | 2013-03-06 | 2014-09-17 | 401d? |  | finish no earlier than 2017-12-12 | S4 | 9968h | 9968h | FS_SEATS | 30 | Knowles, Intel | Rel-15 | 59 | 26.931 | Scott Isabelle (Knowles), David Isherwood (Intel) | Paolo | FS_SEATS |  |
| 902 | 418 | Study on User Services Enhancements in 3GPP for TV Services |  | 328d? | 2016-06-13 A | 2017-09-12 A | 100% |  |  |  |  |  | finish no earlier than 2017-09-12 | S4 | 2624h | 2624h | FS_USE_3GPP_4_TV | 37 | Thomas Stockhammer, Qualcomm Incorporated | Rel-15 | 72 | TR 26.9xx; 26.917 | tsto@qti.qualcomm.com |  |  |  |
| 903 | 419 | Study on Management aspects of selected IoT-related features |  | 322d? | 2016-09-19 A | 2017-12-12 A | 100% |  |  |  |  |  | finish no earlier than 2017-12-12 | S5 | 2576h | 2576h | FS_OAM_IOT | 37 | Cisco Systems / Yanover, Vladimir | Rel-15 | 73 | 32.857 |  |  |  |  |
| 904 | 420 | Study on Overload Control for Diameter Charging Applications |  | 653d? | 2015-06-18 A | 2017-12-15 A | 100% |  |  |  |  |  | finish no earlier than 2017-12-15 | S5 | 5224h | 5224h | FS_DOCME_CH | 35 | GUO Wenjie, ZTE | Rel-15 | 68 | New TR 32.869 | guo.wenjie1@zte.com.cn |  |  |  |
| 905 | 421 | Study on forward compatibility for 3GPP Diameter Charging Applications |  | 194d? | 2016-09-19 A | 2017-06-15 A | 100% |  |  |  |  |  | finish no earlier than 2017-06-15 | S5 | 1552h | 1552h | FS_FWDCA | 37 | Nokia, Maryse <dot> Gardella <at> Nokia <dot> com | Rel-15 | 73 | 32.870 | Nokia, Maryse <dot> Gardella <at> Nokia <dot> com |  |  |  |
| 906 | 422 | Study on OAM aspects of SON for AAS-based deployments |  | 421d? | 2015-11-02 A | 2017-06-09 A | 100% |  |  |  |  |  | finish no earlier than 2017-06-09 | S5 | 3368h | 3368h | FS_OAM_SON_AAS | 36 | Nokia Networks (Yizhi Yao) | Rel-15 | 70 | TR (new) | Yizhi.yao@nokia.com |  |  |  |
| 907 | 423 | Study on Implementation for the Partitioning of Itf-N |  | 534d? | 2016-03-01 A | 2018-03-15 A | 100% |  |  |  |  |  | finish no earlier than 2018-03-15 | S5 | 4272h | 4272h | FS_IMP_ITFN | 36 | Hu, Yaxi, China Mobile | Rel-15 | 71 | New TR 32.880 | huyaxi@cmdi.chinamobile.com |  |  |  |
| 908 | 424 | Study on Management Aspects of Next Generation Network architecture and features |  | 393d? | 2016-06-13 A | 2017-12-12 A | 100% |  |  |  |  |  | finish no earlier than 2017-12-12 | S5 | 3144h | 3144h | FS_MAN_NGNAF | 37 | Nokia Networks, Yizhi Yao | Rel-15 | 72 | TR (new); 28.802 | Yizhi.yao@nokia.com |  |  |  |
| 909 | 425 | Study on Management and Orchestration Architecture of Next Generation Network and Service |  | 393d? | 2016-06-13 A | 2017-12-12 A | 100% |  |  |  |  |  | finish no earlier than 2017-12-12 | S5 | 3144h | 3144h | FS_NGNS_MOA | 37 | Huawei Technologies, Zou Lan | Rel-15 | 72 | TR xy.abc; 28.800 | zoulan@huawei.com |  |  |  |
| 910 | 426 | Study on SON for eCoMP for LTE |  | 263d? | 2016-06-15 A | 2017-06-15 A | 100% |  |  |  |  |  | finish no earlier than 2017-06-15 | R3 | 2104h | 2104h | FS_LTE_SON_eCOMP | 37 | Nokia | Rel-15 | 72 |  |  |  |  |  |
| 911 | 427 | Stopped - Study on IMS Enhanced Spoofed Call Prevention and Detection |  | 849d? | 2014-09-19 A | 2017-12-15 A | 100% |  |  |  |  |  | finish no earlier than 2017-12-15 | S3 | 6792h | 6792h | FS_ESCAPADES | 33 | Sprint | Rel-15 | 64 | 33.832 | Gregory.schumacher@sprint.com |  | FS_ESCAPADES |  |
| 912 | 428 | Study on OAM aspects of LTE and WLAN integration |  | 204d? | 2017-06-05 A | 2018-03-15 A | 100% |  |  |  |  |  | finish no earlier than 2018-03-15 | S5 | 1632h | 1632h | FS_OAM_LWI | 39 | Yizhi Yao, Intel Corporation | Rel-15 | 76 | new; 32.868 | yizhi.yao@intel.com |  |  |  |
| 913 | 429 | Study on Volume Based Charging Aspects for VoLTE |  | 269d? | 2017-06-05 A | 2018-06-14 A | 100% |  |  |  |  |  | start no earlier than 2017-06-05 | S5 | 2152h | 2152h | FS_VBCLTE | 39 | Chen, Ai, China Mobile | Rel-15 | 76 | new; 32.848 | chenai@chinamobile.com |  |  |  |
| 914 | 430 | STOPPED - Study on UE characteristics and performance for Video |  | 339d? | 2016-03-01 A | 2017-06-15 A | 100% |  |  |  |  |  | finish no earlier than 2017-06-15 | S4 | 2712h | 2712h | FS_UE_VTPerf | 36 | Stéphane PROUST, Orange | Rel-15 | 71 | TR 26.932 | stephane.proust@orange.com |  |  |  |
| 915 | 431 | Study on UE Application Layer Data Throughput Performance Expansion for CA |  | 131d? | 2017-12-15 A | 2018-06-15 A | 100% |  |  |  |  |  | finish no earlier than 2018-06-15 | R5 | 1048h | 1048h | FS_UE_App_Data_Perf_CA | 40 | PCTEST Engineering Lab | Rel-15 | 78 |  |  |  |  |  |
| 916 | 432 | Study on system and functional aspects of Energy Efficiency in 5G networks |  | 400d? | 2017-06-05 A | 2018-12-14 A | 100% |  |  |  |  |  | finish no earlier than 2018-12-14 | S5 | 3200h | 3200h | FS_EE_5G | 39 | CORNILY, Jean-Michel, ORANGE | Rel-15 | 76 | new; 32.872; 32.972 | jeanmichel.cornily@orange.com |  |  |  |

Notes:
- 855: 12/7/17: 36.715-05-01 added;19/9/17: Compl:0%->20%; 8/1/18: Compl:20%->50%;27/3/18: Compl:50%->75% ; 27/6/18: Compl:75%->100%;
- 856: ; 19/9/17: Compl:0%->20% 8/1/18: Compl:20%->50%; 27/3/18: Compl:50%->75%; ; 27/6/18: Compl:75%->100%;
- 858: 12/7/17: 36.715-02-02 added;; 19/9/17: Compl:0%->20%; 8/1/18: Compl:20%->40%;27/3/18: Compl:40%->60%; 27/6/18: Compl:60%
- 859: ; 19/9/17: Compl:0%->20%; 8/1/18: Compl:20%->40%;27/3/18: Compl:40%->60%; 27/6/18: Compl:60%->100%
- 861: 12/7/17: 36.715-00-02 added;; 19/9/17: Compl:0%->20% 8/1/18: Compl:20%->50%; 27/3/18: Compl:50%->80%; ; 27/6/18:
- 862: 19/9/17: CD:Sat 15/09/18->Fri 15/06/18; 8/1/18: Compl:0%->50%; 27/3/18: Compl:50%->80% ; 27/6/18: Compl:80%->100%;
- 863: ; 8/1/18: Compl:0%->7%; 27/3/18: Compl:7%->8% ;
- 864: Triggered by Rel-11 TR 37.902 Study on Measurements of radio performances for LTE terminals - TRP and TRS test methodology (FS_LTE_OTA) UID_550022
- 865: ; CD:Wed 18/03/15->Sun 15/03/15; Rel-12->Rel-13; Stat Rep: RP-141158->RP-141973 1st Apr 15: Compl:35%->40% 1st Apr 15: Stat Rep: RP-141973->RP-150104 03/07/15: Stat Rep: RP-150104->RP-150615 29/09/15: Compl:40%->50% 29/09/15: Stat Rep: RP-150615->RP-15
- 866: Stat Rep: RP-141132->RP-141848; Rel 12->Rel13 1st Apr 15: Compl:15%->20% 1st Apr 15: CD:Mon 15/06/15->Wed 15/06/16 1st Apr 15: WID: RP-140090->RP-150070 1st Apr 15: Stat Rep: RP-141848->RP-150069 03/07/15: Compl:20%->25% 03/07/15: Stat Rep: RP-150069->
- 867: follow-up WI of REL-14 WI CIoT_EC_GSM_radio_enh
- 868: follow-up WI of REL-14 WI CIoT_EC_GSM_radio_enh; 27/6/18: Compl:0%->80%;
- 869: follow-up WI of REL-14 WI CIoT_EC_GSM_radio_enh; 27/6/18: Compl:0%->80%;; 10/9/18: 80%->100
- 870: basket CA WI; no Perf. part
- 871: basket CA WI; no Perf. part; 27/6/18: Compl:0%->100%; …
- 872: Perf. Part was introduced and completed at RAN #80
- 873: to add Power Class 1 (+31dBm) for UE operating in Europe @ 450MHz in frequency bands that are suitable for BB-PPDR operation, i.e. band 31 and band 72;
- 874: to add Power Class 1 (+31dBm) for UE operating in Europe @ 450MHz in frequency bands that are suitable for BB-PPDR operation, i.e. band 31 and band 72;27/6/18: moved from Rel-16
- 875: 16/1/19: 0%->100
- 876: -
- 877: -
- 878: 6/10/16: Acronym FS_MA_RVNF ->FS_MA_RNVNF ; 6/10/16: 32.864 added; 1/12/16: 0%->5; 6/3/17: 5%->10; 7/6/17: 10%->40; 11/9/17: 40%->70; 15/12/17: 70%->100; 15/12/17: FCD:09/17->12/17
- 879: CU = central unit, DU = distributed unit; results will be captured in existing TR 38.801; 19/9/17: Compl:0%->30%; 19/9/17: WID: RP-170818->RP-171717; 15/12/17: 38.816 added;; 8/1/18: Compl:30%->95%; 8/1/18: CD:Fr ; 27/6/18
- 880: TR 38.8XX19/6/17: Compl:0%->25%19/6/17: CD:Fri 15/12/17->Thu 15/03/1819/6/17: WID: RP-170717->RP-171450; 30/6/17: 38.811 added;; 19/9/17: Compl:25%->40%; 8/1/18: CD:Thu 15/03/18->Fri 15/06/18; 27/3/18: Compl:40%->45%; 27/6/18: Compl:4
- 881: 19/9/16: 0%->25; 22/9/16: WID:SP-160227->SP-160727; 22/9/16: FCD:12/16->03/17; 1/12/16: 25%->45; 6/3/17: 45%->60; 7/6/17: FCD:03/17->12/17 so Rel-14->Rel-15; 7/6/17: 60%->65; 11/9/17: 65%->100
- 882: 19/9/17: Compl:0%->45%19/9/17: WID: RP-171421->RP-171905; 15/12/17: 38.806 added;; 8/1/18: Compl:45%->100%
- 883: -
- 884: 1/7/16: Compl:0%->50%; 28/7/16: 36.740 added; 26/9/16: WID: RP-161328->RP-161670; 20/12/16: CD:Thu 15/0;21/3/17: CD:Fri 15 12/7/17: 50%->100 since declared as stopped
- 885: 6/10/16: 36.766 added; 20/12/16: Compl:0%->35% 21/3/17: Compl:35%->65%; 19/6/17: Compl:65%->100%
- 886: ; 21/3/17: WID: RP-162541->RP-170403; 21/3/17: 36.754 added;19/6/17: Compl:0%->90%; 19/9/17: Compl:90%->100
- 887: 12/7/17: 36.757 added;; 19/9/17: Compl:0%->35%; 8/1/18: Compl:35%->100%
- 888: -
- 889: 15/12/17: 26.973 added;; 15/12/17: 0%->80; 16/3/18: 80%->100
- 890: 1/7/16: Compl:0%->2%;26/9/16: Compl:2%->5%; 6/10/16: 36.746 added; 20/12/16: Compl:5%->15%;21/3/17: Compl:15%->35%…19/6/17: ;
- 891: 28/7/16: 21.866 added;; 9/6/17: FCD:12/16->9/6/17 (Rel-14->Rel-15); 0%->100
- 892: 13/6/16: WID:SP-150674->SP-160430; 13/6/16: 0%->55; 1/12/16: 55%->80; 6/3/17: FCD:03/17->06/17; 6/3/17: 80%->90; 21/3/17: moved from rel-14; 7/6/17: 90%->100
- 893: TR 38.8XX19/6/17: WID: RP-170837->RP-171093; 12/7/17: 37.885 added;19/9/17: Compl:0%->5%; 8/1/18: Compl:5%->10%; 8/1/18: CD:Fri 15/12/17->Thu 15/03/18; 27/3/18: Compl:10%->30%; 27/3/18: CD:Thu 15/03/18->Fri 15/06/18; 27
- 894: 11/9/17: 0%->15; 15/12/17: 15%->60; 15/12/17: FCD:12/17->03/18; 16/3/18: 60%->100
- 895: 9/6/16: 0%->6; 28/7/16: 23.798 added; 1/12/16: FCD:09/16->12/16; 1/12/16: 6%->15. 7/12/16: Moved from Rel-14 according to SP-160806.; 6/3/17: 15%->50; 7/6/17: 50%->100
- 896: 6/3/17: 0%->5; 7/6/17: 5%->40; 7/6/17: FCD:09/17->12/17; 11/9/17: 40%->50; 15/12/17: 50%->100
- 897: 16/9/16: 0%->15. ; 5/6/17: 15%->70. 5/6/17: moved to Rel-15 (talks with P. Jolivet); 5/6/17: FCD:12/16->09/20; 15/12/17: 70%->100
- 898: 21/3/17: 31.801 added;; 11/9/17: 0%->70; 15/12/17: 70%->100
- 899: TR 25.7XX; 19/6/17: Compl:0%->100%; 12/7/17: 25.708 added;
- 900: TR 36.8XX; 12/7/17: 36.756 added;19/9/17: Compl:0%->40%; 15/12/17: 37.876 added;; 8/1/18: Compl:40%->827/3/18: Compl:85%->100%
- 901: SP#65 completion 09/14=>12/14. Moved to Rel-13. Dec.14: 30->35%, CD 12/14->03/15. Mar.15: CD: 06/16. 40%; June2015: Compl:40%->45. . 15/4/16: moved from R 21/3/17: Moved from Rel-14 (not completed on time); 7/6/17: FCD:06/17->12/17; 11/9/17: 80%->8
- 902: 19/9/16: 0%->30; 6/10/16: 26.917 added; 1/12/16: 30%->60; 1/12/16: FCD:12/16->03/17; 6/3/17: 60%->75; 6/3/17: FCD:03/17->06/17; 21/3/17: Moved from Rel-14 (not completed on time); 7/6/17: 75%->80; 7/6/17: FCD:06/17->09/17; 11/9/17: 80%->100
- 903: 6/10/16: 32.857 added; 1/12/16: 0%->5; 21/3/17: moved from Rel-14; 7/6/17: FCD:06/17->12/17; 7/6/17: 5%->20; 11/9/17: 20%->30; 15/12/17: 30%->45; 16/3/18: 45%->100
- 904: Aug2015: moved to Rel-14 (email CT and EG); 07/09/15: 0%->5; 7/3/16: 5%->10; 13/6/16: FCD:03/16->09/16; 19/9/16: FCD: 09/16->06/17; 6/3/17: FCD:03/17->12/17; 21/3/17: moved from rel-14; 7/6/17: 10%->25; 8/6/17: WID:SP-150310->SP-170481; 11/9/17: 25%->3
- 905: 6/10/16: 32.870 added; 1/12/16: 0%->10; 21/3/17: moved from rel-14; 11/9/17: 10%->40; 15/12/17: 40%->100
- 906: 13/6/16: 0%->40; 19/9/16: FCD:09/16->12/16; 19/9/16: 40%->60; 1/12/16: FCD:12/16->03/17; 1/12/16: 60%->70; 6/3/17: FCD:03/17->06/17; 21/3/17: moved from rel-14; 7/6/17: 70%->100
- 907: 13/6/16: 0%->10; 19/9/16: 10%->35; 1/12/16: 35%->40; 6/3/17: FCD:03/17->03/18; 21/3/17: moved from rel-14; 7/6/17: 40%->60; 11/9/17: 60%->80; 15/12/17: 80%->100
- 908: 28/7/16: 28.802 added; 19/9/16: 0%->5; 1/12/16: 5%->10; 6/3/17: FCD:03/17->06/17; 6/3/17: 10%->40; 21/3/17: moved from rel-14; 7/6/17: FCD:06/17->12/17; 7/6/17: 40%->60; 11/9/17: 60%->70; 15/12/17: 70%->100
- 909: 28/7/16: 28.800 added; 19/9/16: 0%->10; 6/3/17: FCD:03/17->06/17; 21/3/17: moved from rel-14; 7/6/17: FCD:06/17->12/17; 7/6/17: 10%->25; 11/9/17: 25%->30; 15/12/17: 30%->100
- 910: 26/9/16: Compl:0%->10%. ; 20/12/16: Compl:10%->40%21/3/17: Compl:40%->60%; 19/6/17: Compl:60%->100%
- 911: Dec.14: TR number added. 3/3/15: 0->5%; June2015: Compl:5%->25; 9/12/15: 25%->30; 21/3/17: moved from Rel-13; 21/3/17: FCD:09/15->12/17; 7/6/17: Stopped (30%->100%)
- 912: 30/6/17: 32.868 added;; 11/9/17: 0%->10; 15/12/17: 10%->50; 16/3/18: 50%->90; 7/6/18: 90%->100
- 913: 30/6/17: 32.848 added;; 11/9/17: 0%->5; 15/12/17: 5%->35; 16/3/18: 35%->45; 7/6/18: 45%->100
- 914: 11/6/16: 0%->10; 19/9/16: 10%->30, FCD: 12/16->06/17; 21/3/17: Moved from Rel-14 (not completed on time); 7/6/17: Stopped, so 30%->100
- 915: compare REL-11 SI FS_UE_App_Data_Perf; note: SI FS_UE_App_Data_Perf_CA is addressing 2DL/1UL involving also an unlicensed carrier of REL-13 LTE_LAA; instead of a new TR, the TR 37.901 will be updated for REL-15; ;
- 916: 30/6/17: 32.872 added;; 11/9/17: 0%->5; 15/12/17: 32.972 added;; 15/12/17: 5%->40; 16/3/18: 40%->60; 7/6/18: 60%->65; 7/6/18: FCD:06/18->12/18; 10/9/18: 65%->85; 7/12/18: 85%->100
