# Work_plan_3gpp_190315_Rel15_onwrds

Schedule from MS Project, 1999-01-01 to 2026-03-03, A marks actual dates.

## Calendars

- Standard: Mon-Fri 08:00-12:00, 13:00-17:00; Sat-Sun off. Exceptions (off unless hours are given): 2000-01-15 08:00-12:00, 13:00-17:00, 2009-05-30 08:00-12:00, 13:00-17:00, 2011-08-27 to 2011-08-28 08:00-12:00, 13:00-17:00, 2011-09-24 08:00-12:00, 13:00-17:00, 2012-06-02 08:00-12:00, 13:00-17:00, 2012-09-01 08:00-12:00, 13:00-17:00, 2012-11-18 08:00-12:00, 13:00-17:00, 2012-11-24 08:00-12:00, 13:00-17:00, 2013-02-16 08:00-12:00, 13:00-17:00, 2013-06-02 08:00-12:00, 13:00-17:00, 2013-08-10 to 2013-08-11 08:00-12:00, 13:00-17:00, 2013-09-14 08:00-12:00, 13:00-17:00, 2014-03-01 08:00-12:00, 13:00-17:00, 2014-08-24 08:00-12:00, 13:00-17:00, 2014-09-21 08:00-12:00, 13:00-17:00, 2014-10-05 08:00-12:00, 13:00-17:00, 2016-06-18 08:00-12:00, 13:00-17:00, 2021-12-12 08:00-12:00, 13:00-17:00, 2023-09-09 08:00-12:00, 13:00-17:00, 2024-03-03 08:00-12:00, 13:00-17:00, 2024-03-10 08:00-12:00, 13:00-17:00.

## Resources

| Resource |
| --- |
| NP |
| N1 |
| N2 |
| N3 |
| N4 |
| N5 |
| TP |
| T1 |
| T2 |
| T3 |
| RP |
| R1 |
| R2 |
| R3 |
| R4 |
| SP |
| S1 |
| S2 |
| S3 |
| S4 |
| S5 |
| PCG |
| GP |
| No |
| CN4 |
| ? |
| WG G2 |
| G2 |
| G1 |
| G4 |
| G3 |
| All |
| Generic |
| MLST |
| G5 |
| S3, G2 |
| WG T2 |
| GP,G1 |
| G4,G5 |
| OMA |
| GP-G2 |
| Yes |
| GP, |
| N4, |
| GP, N1 |
| CT5 |
| C5 |
| C1 |
| C4 |
| C3 |
| C6 |
| G1, |
| 4 |
| ct |
| c,s,r |
| CT,RAN,SA |
| G2, |
| G1, G3 |
| CT6 |
| CT1 |
| CT1, CT3, CT4 |
| C1, C3, C4 |
| CP |
| R5 |
| C |
| Rel-8 |
| GP, G2 |
| R1,R4 |
| S5,C1 |
| CT,RAN,SA,GERAN |
| S3,C1,C4 |
| 5 |
| S1,C1,C3,C4,S5 |
| S1,C1,C3,C5 |
| S1,C1,C3,C4 |
| S1,S5 |
| S2,S3 |
| RAN,SA |
| RP,S5 |
| S2,CT |
| S1,CT |
| S1,CT,GERAN |
| S1,C5 |
| S3,CT |
| S4,CT |
| C1,SA |
| S1,S2 |
| S1,S4 |
| S2,S2,S3,CT |
| S2,S3,CT |
| S1,CT,GX |
| S1,S4,CT |
| S2,S2,S3,S5,CT |
| S1,S2,CT |
| S1,S2,S3,CT |
| S1,S2,S3,S5CT |
| S1,S2,S3,S5,CT |
| S2,S5,CT |
| S4,S3 |
| S1,C1 |
| CP,C1 |
| C1,C3 |
| C1,C3,C4 |
| S1,S5,CT |
| C4,C3 |
| CP,RAN,SA,GERAN |
| S1,S2,S3,S5,CP |
| S2,S3,CP |
| S2,CP |
| S1,CP,GX |
| S1,CP |
| S1,S4,CP |
| S1,S2,CP |
| S1,S2,S3,CP |
| S2,S5,CP |
| S3,CP |
| S1,S5,CP |
| RAN,SA,GERAN |
| S1,S2,S3,S5,C1,C3,C4,C6 |
| S2,S3,C1,C3,C4 |
| S2,C4 |
| S2,C1,C3,C4 |
| S2,C1,C4 |
| S2,S3,C1,C4 |
| S1,C1,C4,G2 |
| C1,C4 |
| S1,C1,C3 |
| S1,S4,C1,C3,C4 |
| S1,S2,S3,C1,C3,C4 |
| S2,S5,C3 |
| S1,S2,C1,C4 |
| S2,C1 |
| S2,C1,C3 |
| S3,C1,C3,C4 |
| S1,S5,C1,C3,C4 |
| S2,C3,C4 |
| C3,C1 |
| R2,R4 |
| R2,R5 |
| RP,R5 |
| RP,S5,R5 |
| R1,R5 |
| S1,C1,R5 |
| S1,C1,S4,R5 |
| GERAN |
| G3new |
| G1, G3new |
| C4,C1,C3 |
| R1.R4 |
| R1, R4 |
| R2,R3 |
| C3,C4 |
| S4,C3 |
| S4,C3,C1,C4 |
| S1,S2,C1 |
| S1,S2<C1,C3,C4 |
| S1,S2,C1,C3,C4 |
| S5,C1,C3,C4 |
| GP,C4 |
| C4,C1 |
| S2,S1 |
| RP,SP,GP |
| RP,SP,CP,GP |
| CP,GP,RP,SP |
| GP,C4,S4 |
| S1,C1,C4 |
| S1,S2,C3,C1 |
| R2,R4,R3 |
| CP,GP, RP,SP |
| S2,S1,C1,S5 |
| S2,S1,C1 |
| S1,C1,S4 |
| S1,S2,GP,C4,R2 |
| S1,GP,R2 |
| S1,C6 |
| S1,S2,C1,S4 |
| S2,S3,S5,C1,C3,C4 |
| S2,S5,C1 |
| S2,S3,S5 |
| CP,GP, RP,SP,TP |
| S2,C4,C1 |
| S1,C1,C4,S3 |
| S2,S5 |
| S3,C1 |
| S3,C4 |
| S1,C4 |
| S2,S5,C3,C1 |
| S2,S1,S5,C1,C4 |
| S1,R1,C3 |
| S1,C1,R2 |
| S2,S1,C1,C4 |
| S1,C1,C6 |
| GP,S4,C4,C1,C3 |
| C3,C1,C4 |
| S1,C4,C1 |
| S1,S3 |
| S1,S2,S5,C3,C4 |
| R4,G1 |
| G1,R4 |
| RP,GP |
| R4,GP |
| R3,R2 |
| C6,RP,SP |
| R5,C6 |
| CP,RP,SP |
| RP,SP,CP |
| R3,S5 |
| S1,S2,RP |
| S1,S2,S5,RP |
| S2,S1,RP |
| Rel-9 |
| S3,C6 |
| S1,S2,S3,S5,RP |
| S2,S1,S3 |
| S1,S2,S3 |
| S1,S2,S3,S5 |
| C6,R5 |
| S1,S2,RP,GP |
| S1,S2,S4,S5,RP,GP |
| GP,G2 |
| GP,GP, N1 |
| GP,S2,G1,G2 |
| GP,R2,R3,S2,G1,G2 |
| GP,S2,S5,R2,R3,G2,G1 |
| GP,R3 |
| N4,S2 |
| GP,RP |
| GP,S2,RP |
| G5,G4 |
| G4,R3 |
| S2,R2,R4 |
| S1,S2,R2,R4 |
| GP,S5 |
| S1,S2,S5 |
| R4,R5 |
| R4,R2,R3,R5 |
| S2,S5,N4,RP |
| S1,S2,S3,S5,NP |
| S2,S4,S5 |
| T2,S1,S4,S5 |
| SP,RP |
| S2,RP |
| S1,S2,CP,G2 |
| CP,SP |
| S1,G2 |
| SP,CP |
| S1,S2,S5,C3 |
| S1,C1,S3 |
| G1,G3new |
| C4, C3, C1C4 |
| C4,C3,C1 |
| S1,S2,S3,S5,R2,R3,R4 |
| S1,S2,S3,R2 |
| S2,S3,S5,C4,R2 |
| S1,S5,C1 |
| S1,S2,S3,C1,C3,C4,R2 |
| Ggp |
| S3,S2,C1,C4,G2 G3new |
| R1,R2,R3,R4 |
| R4,R1,R2,R3 |
| R4,R2,R3 |
| S1,C1,C4,R2 |
| R4,R2 |
| S2,C4,R2,R4 |
| S2,C4,R2 |
| S2,S3,S5,C3,C4,R2 |
| S1,S2,S4,T2 |
| S1,S2,S4 |
| S1,S2,S4,R5 |
| S3,S2,C1,C4,G2,G3new |
| GP,C1 |
| S1,S5,C4 |
| S1,S2,S3,S5,R2,R3,R4,GP |
| GP,C4,C3,C1 |
| SMG9 |
| SMG1 |
| SMG2 |
| N3,R5 |
| N1, N2, N4, G1, G2, R3, S1, SMG2 |
| S1,SMG1 |
| SMG1,N4 |
| N1,C1,N4,S1,T2,G2,SMG1,SMG2,SMG3,SMG7,SMG9 |
| SMG1,N2 |
| S1,S2,N2,N4 |
| N4,N2 |
| G1,G2 |
| G1,G2,C1 |
| G1,G2,N1 |
| SMG2, SMG1, SMG3, SMG4, SMG7, SMG9, SMG10, G1, G2, G3, N1, N3, T2 |
| SMG2,G1 |
| S1,G1,G2 |
| SMG1,N1,G1,G2 |
| G2,G1 |
| G1,G2,G3,S1,S2,SMG1,SMG2,SMG7,N1,N2,N3,N4,T2 |
| 23.003, 23.008, 29.060 |
| S1, S2, SMG1, SMG2, SMG12, G2, N1, N2, N4 |
| S1,S2,SMG1,SMG2,SMG12,G2,N1,N2,N4 |
| S1,SMG2,N1,N2,N4 |
| SMG1,T2 |
| S1,N1,N2,N4 |
| S1,S2,N5 |
| SMG2,SMG7,G2,T2 |
| S3,N1,N2,N3 |
| S3,N1,N2,N4 |
| SMG9,T3 |
| SMG2,SMG3,SMG7,G2,N2 |
| SMG2,N1,G1,G2 |
| S1,N2 |
| N1,N3 |
| S2,N1 |
| N1,N2,N4 |
| N2,N1,N4 |
| N2,N4 |
| S1,T3 |
| T2,N3 |
| S3,N2 |
| T2,S1 |
| S1,N4 |
| SMG1,SMG2,SMG7 |
| N1,S1,T1 |
| SMG1,SMG3 |
| N4,S2,N1 |
| S1,S2,SMG1,SMG2,SMG7,G1,G2,G3,N1,N2,N3,N4,T2 |
| SMG1,N3 |
| S1,N3 |
| CP,SP,SMG |
| CP,SP,TP,GP,SMG |
| NP,SP,TP,GP,SMG |
| NP,GP, RP,SP,TP |
| SMG2,SMG1,SMG3,SMG4,SMG7,SMG9,SMG10,G1,G2,G3,N1,N3,T2 |
| S1,N2,N4 |
| S1,S2,S3,C1,C3,C4,R2,R3 |
| R2,R3,R1,R4 |
| R2,R3,R4 |
| R2,R1,R3,R4 |
| S2,C4,R2,R3,R4 |
| S2,C4,R2,R1,R3,R4 |
| S2,S3,S5,C3,C4,R2,R3,R4 |
| R1,R2,R4 |
| R3,R1,R4 |
| S2, |
| S2,G2, |
| S1,S2,G2, |
| S1,S2,G2,R2,R3, |
| S1,S2,C4,G2,R2,R3 |
| S1,S2,N4,G2,R2,R3 |
| S1,S2,SMG1,SMG2,SMG12,G2,N1,N2,N4,R2,R3 |
| S1,SMG1,T2 |
| S1,SMG1,S2 |
| S1,N4,N2 |
| T2,N1,N3 |
| S3,N2,N4 |
| SMG1,SMG2,SMG3,SMG7,SMG9,N1,C1,N4,S1,T2,G2 |
| SMG1,N2,N4 |
| S2,T2,N1,N2,N4 |
| S1,T2 |
| S1,S2,C4 |
| S1,S2,N4,RP |
| S2,N4 |
| S1,S2,N3,N4,RP |
| S1,S2,SMG1,SMG2,SMG12,T2,G2,N1,N2,N4,R2,R3 |
| S1,T2,N1,N3 |
| S1,S2,SMG1,SMG2,SMG12,T2,G2,N1,N2,N3,N4,R2,R3 |
| S1,S2,S3,SMG1,SMG2,SMG12,G2,N1,N2,N4,R2,R3 |
| S1,S2,SMG,G1,G2,G3,N1,N2,N3,N4,T2 |
| S1,S2,SMG,T2,G2,N1,N2,N3,N4,R2,R3 |
| S1,S3,SMG,G1,G2,G3,N1,N2,N3,N4,T2 |
| S1,S3,T2,N2,N4 |
| S1,S2,SMG,T2,G1,G2,G3,N1,N2,N3,N4 |
| G2,S2 |
| T1,R5 |
| R5,T1 |
| S1,S2,S4,T1,R5 |
| S1,S2,S4,S5,T1,RP,GP |
| S1,S2,S3,S5,R2,R3,R4,GP,C1 |
| S1,S2,S3,SMG1,SMG2,SMG12,N1,N2,N4,R2,R3 |
| S1,S2,SMG,T2,N1,N2,N3,N4,R2,R3 |
| NP,SP,TP,SMG |
| S1,S2,SMG,T2,N1,N2,N3,N4 |
| SMG,N1 |
| SMG |
| S1,S2,SMG1,SMG2,SMG7,N1,N2,N3,N4,T2 |
| SMG2,SMG1,SMG3,SMG4,SMG7,SMG9,SMG10,N1,N3,T2 |
| S1,SMG |
| SMG2,SMG7,T2 |
| SMG2,S2 |
| N1,N2,N4,R3,S1,SMG |
| SMG2,SMG3,SMG7,N2 |
| SMG1,SMG2,SMG3,SMG7,SMG9,N1,C1,N4,S1,T2 |
| S1,S2,SMG,N3,N4,RP |
| S1,S2,S4,SMG,N3,N4,RP |
| S2,C1,C4,R2,R1,R3,R4 |
| R2,S2,S4 |
| G3new,R5 |
| GP,R4 |
| S2,S4,R2 |
| SP,GP |
| RP,SP |
| S2,S1,S3,S5 |
| S3,S1 |
| N4,N1,N2,S2 |
| S2,G1,G2,R2,R3 |
| S2,G1,G2 |
| G1,G2,R2,R3 |
| N4,T3 |
| S3,S2,N1,N4,T3,OMA |
| T2,S1,S4,S5,OMA |
| S2,N3 |
| S4,S1 |
| N4,N3,S1 |
| R5,G3new |
| R4,R2,R1 |
| S2,R2 |
| C3, C4,C1 |
| S3,C1,C4,C3 |
| C1,C4,C3 |
| S2,C1,C4,C3 |
| R3,R5 |
| S1,S2,C3 |
| R1,R2 |
| S3,C1,C4,G2,G3new |
| R1,R3 |
| GP,N1 |
| R1,R2,R3 |
| R3,R2,R4 |
| R4,R3 |
| S1,S2,R2,R3 |
| S1,S2,S3,C1,C3,C4,R2,R3,R5 |
| S2,S1,S5 |
| C4, C1 |
| C3, C1, C4 |
| S2,S1,S3,S5,C4,C1 |
| S2,C3,C1,C4 |
| S2,S1,S5,C3 |
| GP,S2,C1 |
| GP,S2,C1,G2 |
| G2,S2,C1 |
| v |
| G3new,G1,G2 |
| G1,G2,C1,G3new |
| S2,S1,S5,C1,C3 |
| C1,C3,C4,R5 |
| R2,R1 |
| S1<S2,N1,R2,R5 |
| S1,S2,N1,R2,R5 |
| S2,R5 |
| S1,S2,S5,R5 |
| S2,C1,C4,R2,R1,R3,R4,R5 |
| S1,S2,S3,S5,NP,R5 |
| S1,S2,S4,S5,RP,R5,GP |
| S1,S2,S3,S5,C1,C6,R2,R3,R4 |
| S1,S2,S3,S5,C1,C6,R2,R3,R4,GP |
| S4,R2 |
| S1,S2,C1,C4,G2 |
| S4,C3,C4 |
| S5,C1,C4 |
| S2,C4,C3,C1 |
| C4, C3, C1 |
| S2,S4,R2,C4,C3,C1 |
| GP1,GP2 |
| GP,GP1,GP2 |
| GP,G1,G2 |
| G2,R3 |
| S1,S2,S3,C1,C3,C4,G2 |
| GP,G1,C1 |
| S1,S2,C4,C3,C1 |
| - |
| GP,G1,G2,G3new |
| S1,S2,S3,C1,C3,C4,G2,R2,R3 |
| S1,S2,C1,C3,C4,G2,R2,R3 |
| C1,C6 |
| GP,G2,C4 |
| S2,C3 |
| R5,R4 |
| C4,GP,G2 |
| S1,S2,C1,C4,G2,R2,R3 |
| R1,R2,R4,S3 |
| S2,S5,C3,C1,C4 |
| S2,S4,C4,C3,C1 |
| S2,S4 |
| S3,S1,S2 |
| S1,S2,S3,C1,R2 |
| S3,S1,S2,C1,R2 |
| S2,C3,S5 |
| S1,S2,C1,C4,C3,G2,R2,R3 |
| S5,C4 |
| S2,S1,C3 |
| C1,C4,C3,C6 |
| S1,S2,C1,C4,C3,C6,G2,R2,R3 |
| R1,R2,R4,S3,C4,C6 |
| R4,R1,R4,R1,R2,R3,R3 |
| S2,R3,R2 |
| S1,S2,S5,CP |
| S1,S3,CP |
| C6,C1 |
| R4,R2,R1,R3 |
| R3,R1,R2 |
| R1,R4,R2,R3 |
| S2,C4,C1,C3 |
| R3,R1,R2,R4 |
| C4,S1 |
| S2,S5,R3,GP, |
| S2,S5,R3,GP |
| S1,S2,S3,S5,C1,C3,C4 |
| S2,S3,S5,C1,C3,C4,C6 |
| S5,S1 |
| 03.06.2011 |
| CT1 CT3, CT4 |
| CT3, |
| CT4 |
| CT3 |
| GP,G2,G1 |
| S5,S1,C1 |
| SP,RP,CP |
| SP,CP,GP,RP |
| R1,R2,R4,R3 |
| R4,R2,R5 |
| R2,R4,R5 |
| R1,R2,R4,S2,S3,C4,C6 |
| C1-IETF |
| S4-IETF |
| C1-IETF, C3-IETF, C4-IETF |
| S3-IETF |
| C4-IETF |
| C1-IETF, C3-IETF |
| S2,S4,C1,R2 |
| S2,S4,C3,C4 |
| S2,S4,C1,C3,R2 |
| S1,S2,C1,IETF |
| S4,IETF |
| C1,C4,IETF |
| S2,S4,C1,C3,R2,IETF |
| S3,C1,C4,C3,IETF |
| S3,C4,IETF |
| C1,IETF |
| S1,S2,S3,S5,C1,C3,C4,C6,IETF |
| S2,S3,C1,C4,IETF |
| S1,S2,C1,C3,C4,IETF |
| C1,C3,C4,IETF |
| S1,S5,C1,C3,C4,IETF |
| C1,C3,IETF |
| S2,C1,C3,C4,IETF |
| S2,S4,C3,C4,IETF |
| S5,C1,C4,IETF |
| S5,C1,C3,C4,IETF |
| S2,S3,S5,C1,C3,C4,IETF |
| S2,IETF |
| S3,C1,C3,C4,IETF |
| S2,S3,C1,C3,C4,IETF |
| S3,S2 |
| S3,S2,C1 |
| S3,S1,S2,C1 |
| S2,S5,N3 |
| S1,S2,S3,S5,N1,N3,N4,T3 |
| S5,N4,R3 |
| S1,S2,S5,C1,C4,C3,C6,G2,R2,R3 |
| S2,N1,N4,R3,GP |
| T2,S3 |
| S3,N4,N1 |
| S2,N3,N4 |
| S3,T2 |
| S2,S1,S3,S5,RP,GP |
| S1,S2,S3,S5,R5 |
| S1,S2,S3,S5,NP,T3,T1,R5 |
| S3,T3 |
| GP,S3 |
| S1,S2,S3,S4,S5,RP,R5,GP |
| N1,N4 |
| S1,S2,S3,S4,N1,N3,N4,OMA |
| S2,C1,C3,C4,G2,R2,R3 |
| S1,C4,C3 |
| S2,S1,C1,C4,IETF |
| C1,C3,C4,C6 |
| C4,C1,C6 |
| S1,S2,S3,C1,C3,C4,C6 |
| S2,S1,C1,C3,C4 |
| S1,S2,C1,C3 |
| C1.IETF |
| C1-IETF,C4-IETF |
| G1,C1 |
| G1,S2,C4 |
| G2,S2,C4 |
| R1,R2,R3,R4,R5 |
| R2,R4,R3,R5 |
| R3,R2,R5 |
| R2,R3,C1,C6 |
| S1,S2,S3,C1,C3,C4,C6,R2,R3 |
| R4,R1 |
| S2,S4,C4,C3,C1,IETF |
| S2,C4,C3 |
| S3.C4,C1 |
| G2,C4 |
| R4,G1,G3new |
| C4,G2 |
| S3,C4,C1 |
| R2,R3,R5 |
| R1,R2,R4,R5 |
| S1,S2,S3,S5,C1,C6,R2,R3,R4,R5,GP |
| S1,C1,C4,R2,R5 |
| S2,S3,S5,C3,C4,R2,R3,R4,R5 |
| R2,R1,R3,R4,R5 |
| S3-IETF, C1-IETF |
| S3-IETF,C1-IETF |
| C1-IETF,C3-IETF |
| S2-IETF |
| S2,S1,C1,C3,C4,IETF |
| 25.101, 25.104, 25.141, 25.317 |
| S1,G2,S2,C1 |
| S1,C1,C4,R2,R3,R5 |
| S5,S2 |
| S4,C3,C4,IETF |
| S4,S3,C3,C4,IETF |
| S4,S3,C3,C4 |
| S4,S3,IETF |
| S1,S2,S3,S5,C1,C3,C4,C6,R2,R3 |
| C1,C4,C6 |
| S1,S2,S5,C1,C4,C6,G2,R2,R3 |
| GP,G1,C1,G3new |
| S2,S5,C1,C3 |
| C4,C3,G2 |
| S2,S1,S5,C3,C1,C4 |
| C3,C4,C1 |
| S2,S1,S5,C3,C4,C1 |
| RAN1 |
| RAN2 |
| RAN3 |
| RAN4 |
| R4,R2,R3, |
| Feasibility Study on LTE Device to Device Communications – Radio Aspects |
| SMG1,SMG2,SMG3,SMG7,SMG9,N1,N4,S1,T2 |
| C3-IETF, C4-IETF |
| S3-IETF,C1-IETF,C3-IETF |
| C3-IETF |
| C3,IETF |
| S2,C1,C4,C3,IETF |
| S1,S2,S3,C1,C3,C4,R2,R3,R5,IETF |
| C1-IETF,C3-IETF,C4-IETF |
| C4,C1,C3,IETF |
| S2,C4,C1,C3,IETF |
| C1,C4,C3,IETF |
| S2,S1,T2,N1,N4,R3,R2 |
| S2,S1,S2,S1,N1,N4 |
| S2,S1,N1,N4 |
| S2,R2,G1 |
| S2,S1,S3,S5,N4,R2,R3,GP |
| S1,S2,N4 |
| S2,OMA |
| S2,N4,OMA |
| S2,S5,N4,R2,R4 |
| S2,S5,N4,R2,R4,OMA |
| GP,R2 |
| S1,S2,GP,R2 |
| G1,G3 |
| S1,G2,R2 |
| S2,S5,N4,R2,R4,R5,OMA |
| SR5 |
| S3,C4,C1,R5 |
| S3,S1,C1 |
| S2,C4,C3,G2 |
| SP,CP,RP |
| S3,R5 |
| GP,G2,G3new |
| S1,S2,S3,S4,S5,N1,N3,RP,R5,GP |
| S1,S2,S3,S4,S5,N1,N3,RP,R5,T1,GP |
| S1,S2,S3,S4,S5,N1,N3,RP,R5,T1,GP,G2,G3new |
| S1,S2,S3,S4,S5,N1,N3,R2,R4,R5,T1,GP,G2,G3new |
| S1,S2,S5,C1,C4,C6,G2,R2,R3,G3new |
| SP,CP,RP,GP |
| G2,G1,G3new |
| G2,G1,C1,G3new |
| RAN |
| R |
| S2,S1,S3,S5,R2 |
| S2,S1,S3,S5,R2,R3 |
| S1,S2,S5,C1,C4,C6,G2,R2,R3,R5,G3new |
| C1,C4,R5,IETF |
| C1,R5 |
| R3,R1 |
| R3,GP |
| S3,IETF |
| S1,S2,S5,C1,C3,C4,C6,R2,R3 |
| S3,C4,C1,C3 |
| C1,C4,S1 |
| C1,C4,R3 |
| R2,R1,R3 |
| R1,R4,R2,R3,R5 |
| RAN5 |
| S2,C4,C1,R3 |
| G1,G2,G3new |
| S4,C1 |
| S4,C4,C1,C3 |
| 14/06/2013 08:00 |
| S2,C1,C3,IETF |
| C3, C1 |
| R3,C4 |
| S2,S1,C1,C3 |
| R3,S2,C4 |
| R% |
| G1,C1,G3new |
| R3,S2,C4,G2 |
| S1,S3,N4 |
| S1,OMA |
| S1,S2,S4,OMA |
| S5,S2,N3 |
| S3,C4,C1,C3,IETF |
| S1,S2,S5,C1,C3,C4,C6,R2,R3,R5 |
| S2,S1,S5<c3 |
| S2,C1,C4,C6 |
| S2,S1,S3,C1,C4,C6 |
| S2,S1,S3,C1 |
| R2,R3,R4,G2,G1,G3new |
| C1,C3,R5 |
| ,C4,C6 |
| S2,S1,S3,C1,C4,C6,R2 |
| S2,S1,S3,C1,C4,C6,R2,R3 |
| S2,S1,S3,C1,C3,C4,C6,R2,R3 |
| S1,S2,S3,IETF |
| S1,S2,S3,C1,C3 |
| S1,S2,S3,C4,C1,C3 |
| C1,S1 |
| C34 |
| S1,S2,S3,C1,C4,IETF |
| IETF |
| SMG12 |
| SMG7 |
| SMG3 |
| SMG4 |
| SMG10 |
| C3-IETF,C4-IETF |
| NP,GP,RP,SP,TP |
| S3,G2 |
| R2,S2 |
| R2,S2,C1 |
| R2,C1 |
| S1` |
| R2,S1,C1 |
| C1-IET |
| 18/06/2014 08:00 |
| C4-IET |
| RAN1 (primary) |
| C3.S2 |
| C3-IET |
| S6 |
| ` |
| SA5 |
| Rel-13 |
| Rel-14 |
| 18/06/2015 |
| SA2 |
| S3-IET |
| SA1 |
| SA4-IETF |
| R6 |
| S3LI |
| ITU-R AH |
| Rel-15 |
| CT1-IETF |
| FRASE |
| SP-180438 |
| SP-180439 |
| SP-180440 |
| SP-180441 |
| SP-180442 |
| SP-180443 |
| SP-180387 |
| SP-180388 |
| SP-180390 |
| SP-180391 |
| S5-IETF |
| ITU-RAH |
| 0% |
| S4_ |

## Schedule

| ID | WBS | Task | Type | Duration | Start | Finish | Complete | Remaining | Total slack | Constraint | Resources | Work | Actual work | Release | Acronym | WI rapporteur name | WI rapporteur e-mail | Impacted TSs and TRs | PCG approved | TSG approved | Status Report |
| --- | --- | --- | --- | --- | --- | --- | --- | --- | --- | --- | --- | --- | --- | --- | --- | --- | --- | --- | --- | --- | --- |
| 1 | 1 | Work Plan 3GPP version April 3rd 2024 |  | 1d? | 2019-03-07 | 2019-03-07 |  |  | 1827d |  |  |  |  | Rel-19 |  |  |  |  |  |  |  |
| 2 | 2 | Post TSG#103 version |  | 1d? | 2019-03-07 | 2019-03-07 |  |  | 1827d |  |  |  |  | Rel-19 |  |  |  |  |  |  |  |
| 3 | 3 | Next key milestones: Rel-18 (St.3 & RAN): Mar 24. Rel-19: ST.2: Dec 24; St.3: Sept.25 |  | 1d? | 2019-03-07 | 2019-03-07 |  |  | 1827d |  |  |  |  | Rel-19 |  |  |  |  |  |  |  |
| 5 | 4 | --- RELEASE 20 --- | milestone | 0d? | 2019-03-07 | 2019-03-07 |  |  | 1828d |  |  |  |  | Rel-19 |  |  |  |  |  |  |  |
| 6 | 5 | Study on satellite access - Phase 4 |  | 240d | 2024-04-02 | 2025-03-03 |  |  | 261d | start no earlier than 2024-04-02 | S1 | 1920h |  | Rel-20 | FS_5GSAT_Ph4 | Thierry Bérisot, Novamint | tberisot@novamint.com |  |  |  |  |
| 7 | 6 | Study on FRMCS Phase 6 |  | 129d | 2024-03-13 | 2024-09-09 |  |  | 386d | finish no earlier than 2024-09-09 | S1 | 1032h |  | Rel-20 | FS_FRMCS_Ph6 | Nikolopoulou, Vassiliki, UIC, | nikolopoulou@uic.org | 22.989 |  |  |  |
| 8 | 7 | Study on Energy Efficiency as Service Criteria Phase 2 |  | 240d | 2024-04-02 | 2025-03-03 |  |  | 261d | start no earlier than 2024-04-02 | S1 | 1920h |  | Rel-20 | FS_EnergyServ_Ph2 | Laurent-WalterGoix, Nokia | laurent-walter.goix@NOKIA.COM |  |  |  |  |
| 9 | 8 | --- RELEASE 19 --- | milestone | 0d? | 2019-03-07 | 2019-03-07 |  |  | 1828d |  |  |  |  | Rel-19 |  |  |  |  |  |  |  |
| 10 | 9 | Rel-19 Energy Efficiency, Energy Saving | milestone | 0d? | 2016-03-15 A | 2016-03-15 A | 100% |  |  | start no earlier than 2016-03-15 |  |  |  | Rel-19 |  |  |  |  |  |  |  |
| 11 | 10 | **Energy Efficiency as Service Criteria** |  | 664d | 2022-06-02 A | 2024-12-12 | 57% | 285.84d | 318d |  |  | 8368h | 3744h | Rel-19 | EnergyServ | Xiaonan Shi, CMCC | shixiaonan@chinamobile.com | 22.261 | 51 | 100 |  |
| 12 | 10.1 | Study on Energy Efficiency as service criteria |  | 333d | 2022-06-02 A | 2023-09-09 A | 100% |  |  | finish no earlier than 2023-09-09 | S1 | 2664h | 2664h | Rel-19 | FS_EnergyServ | Xiaonan Shi, CMCC | shixiaonan@chinamobile.com | 22.882 | 49 | 96 |  |
| 13 | 10.2 | Stage 1 of Energy Efficiency as Service Criteria |  | 135d | 2023-06-08 A | 2023-12-12 A | 100% |  |  | finish no earlier than 2023-12-12 | S1 | 1080h | 1080h | Rel-19 | EnergyServ | Xiaonan Shi, CMCC | shixiaonan@chinamobile.com | 22.261 | 51 | 100 |  |
| 14 | 10.3 | Study on Energy Efficiency and Energy Saving |  | 196d | 2023-09-09 A | 2024-06-05 | 55% | 88.2d | 454d | finish no earlier than 2024-06-06 | S2 | 1568h |  | Rel-19 | FS_EnergySys | Jungshin Park (Samsung) | shin02.park@samsung.com | SP-231192; 23.700-66; 28.880 | 51 | 101 |  |
| 15 | 10.4 | Study on energy efficiency and energy saving aspects of 5G networks and services |  | 199d | 2023-12-08 A | 2024-09-09 | 10% | 179.1d | 386d | finish no earlier than 2024-09-09 | S5 | 1592h |  | Rel-19 | FS_Energy_OAM_Ph3 | Jean-Michel Cornily (Huawei) | jean.michel.cornily@huawei.com | 28.866 | 52 | 102 |  |
| 16 | 10.5 | Study on security aspects of energy saving in 5G |  | 183d | 2024-04-02 | 2024-12-12 |  |  | 318d | start no earlier than 2024-04-02 | S3 | 1464h |  | Rel-19 | FS_Energy_Sec | Bo Bjerrum | bo.bjerrum@nokia.com | 33.766 |  |  |  |
| 17 | 11 | **Enhancements of Network energy savings for NR** |  | 582d | 2023-12-13 A | 2026-03-03 | 2% | 573.18d | 0d |  |  | 12048h |  | Rel-19 | Netw_Energy_NR_enh | Ericsson |  |  | 52 | 102 |  |
| 18 | 11.1 | Core part: Enhancements of Network energy savings for NR |  | 457d | 2023-12-13 A | 2025-09-09 | 5% | 434.15d | 125d | finish no earlier than 2025-09-09 | R1 | 3656h |  | Rel-19 | Netw_Energy_NR_enh-Core | Ajit Nimbalker, Ericsson | Ajit.Nimbalker@ericsson.com |  | 52 | 102 | RP-240169 |
| 19 | 11.2 | Perf. part: Enhancements of Network energy savings for NR |  | 582d | 2023-12-13 | 2026-03-03 |  |  | 0d | finish no earlier than 2026-03-03 | R4 | 4656h |  | Rel-19 | Netw_Energy_NR_enh-Perf | Ajit Nimbalker, Ericsson | Ajit.Nimbalker@ericsson.com |  | 52 | 102 | RP-240169 |
| 20 | 11.3 | UE Conformance - Network energy savings for NR |  | 467d | 2024-03-03 | 2025-12-12 |  |  | 57d | finish no earlier than 2025-12-12 | R5 | 3736h |  | Rel-18 | Netw_Energy_NR-UEConTest | Huawei |  |  |  |  |  |
| 21 | 12 | Study on Media enerGy consumption exposuRE and EvaluatioN framework |  | 240d | 2024-04-02 | 2025-03-03 |  |  | 261d | start no earlier than 2024-04-02 | S4 | 1920h |  | Rel-19 | FS_MediaEnergyGREEN | Julien Lemotheux, Orange, | julien.lemotheux@orange.com |  |  |  |  |
| 22 | 13 | **Low-power wake-up signal and receiver for NR (LP-WUS/WUR)** |  | 582d | 2023-12-13 A | 2026-03-03 | 4% | 561.53d | 0d |  |  | 8312h |  | Rel-19 | NR_LPWUS | vivo |  |  | 52 | 102 |  |
| 23 | 13.1 | Core part: Low-power wake-up signal and receiver for NR (LP-WUS/WUR) |  | 457d | 2023-12-13 A | 2025-09-09 | 8% | 420.44d | 125d | finish no earlier than 2025-09-09 | R1 | 3656h |  | Rel-19 | NR_LPWUS-Core | Xueming Pan, vivo | panxueming@vivo.com |  | 52 | 102 | RP-240134 |
| 24 | 13.2 | Perf. part: Low-power wake-up signal and receiver for NR (LP-WUS/WUR) |  | 582d | 2023-12-13 | 2026-03-03 |  |  | 0d | finish no earlier than 2026-03-03 | R4 | 4656h |  | Rel-19 | NR_LPWUS-Perf | Xueming Pan, vivo | panxueming@vivo.com |  | 52 | 102 | RP-240134 |
| 25 | 14 | Rel-19 Artificial Intelligence (AI)/Machine Learning (ML) | milestone | 0d? | 2016-03-15 A | 2016-03-15 A | 100% |  |  | start no earlier than 2016-03-15 |  |  |  | Rel-19 |  |  |  |  |  |  |  |
| 26 | 15 | Study on AI/ML Model Transfer Phase2 |  | 393d | 2022-03-10 A | 2023-09-09 A | 100% |  |  | finish no earlier than 2023-09-09 | S1 | 3144h | 3144h | Rel-19 | FS_AIML_MT_Ph2 | Yang Xu, OPPO | xuyang@oppo.com | 22.875; 22.876 | 48 | 95 |  |
| 27 | 16 | AI/ML Model Transfer Phase 2 |  | 135d | 2023-06-08 A | 2023-12-12 A | 100% |  |  | finish no earlier than 2023-12-12 | S1 | 1080h | 1080h | Rel-19 | AIML_MT_Ph2 | Yang Xu, OPPO | xuyang<at>oppo.com | 22.261 | 51 | 100 |  |
| 28 | 17 | Study on Core Network Enhanced Support for Artificial Intelligence (AI)/Machine Learning (ML) |  | 113d | 2024-01-04 A | 2024-06-06 | 25% | 84.75d | 453d | finish no earlier than 2024-06-06 | S2 | 904h |  | Rel-19 | FS_AIML_CN | Xiaobo Wu, vivo | xiaobo.wu@vivo.com) |  | 52 | 102 |  |
| 29 | 18 | Study on security aspects of Core Network Enhanced Support for AIML |  | 183d | 2024-04-02 | 2024-12-12 |  |  | 318d | start no earlier than 2024-04-02 | S3 | 1464h |  | Rel-19 | FS_AIML_CN_SEC | Chang Liu, | liuchangyjy@chinamobile.com | 33.784 |  |  |  |
| 30 | 19 | Study on AI/ML management - phase 2 |  | 180d | 2024-01-03 | 2024-09-06 |  |  | 387d | start no earlier than 2024-01-03 | S5 | 1440h |  | Rel-19 | FS_AIML_MGT_Ph2 | Yizhi Yao (Intel) | yizhi.yao@intel.com |  | 52 | 102 |  |
| 31 | 20 | Study on application layer support for AI/ML services |  | 265d | 2023-09-07 A | 2024-09-06 | 55% | 119.25d | 387d | finish no earlier than 2024-09-09 | S6 | 2120h |  | Rel-19 | FS_AIMLAPP | Pateromichelakis, Emmanouil (Manos) | epateromiche@lenovo.com | 23.700-82 | 51 | 101 |  |
| 32 | 21 | Study on enhancements for Artificial Intelligence (AI)/Machine Learning (ML) for NG-RAN |  | 196d | 2023-12-13 | 2024-09-09 |  |  | 386d | finish no earlier than 2024-09-09 | R3 | 1568h |  | Rel-19 | FS_NR_AIML_NGRAN_enh | ZTE |  | 38.743 | 52 | 102 |  |
| 33 | 22 | Study on Artificial Intelligence (AI)/Machine Learning (ML) for mobility in NR |  | 1510d | 2019-03-07 | 2024-12-12 |  |  | 318d | finish no earlier than 2024-12-12 | R2 | 12080h |  | Rel-19 | FS_NR_AIML_Mob | Zhongda Du, OPPO | duzhongda@oppo.com | 38.744 | 52 | 102 | RP-240083 |

Notes:
- 5: -
- 9: -
- 10: -
- 11: ; 6/9/23: 0%->75; 8/12/23: 75%->100
- 12: 13/7/22: 22.882 added;; 9/9/22: 0%->10; 10/12/22: FCD:10/03/2023->06/23; 10/12/22: 10%->40; 16/3/23: WID:SP-220446->SP-230235; 17/3/23: 40%->70; 8/6/23: 70%->90; 8/6/23: FCD:06/06/2023->09/20; 6/9/23: 90%->95; 8/12/23: 95%->100
- 13: ; 6/9/23: 0%->75; 8/12/23: 75%->100
- 14: 9/23: company-submitted WID, to be corrected; 6/10/23: 23.700-66 added;; 8/12/23: 0%->15; 4/1/24: 28.880 added;; 14/3/24: 15%->55
- 15: 4/1/24: 28.866 added;; 14/3/24: 0%->10
- 16: 3/4/24: 33.766 added;
- 17: 2/4/24: WID:RP-234065->RP-240170
- 18: 14/3/24: Compl:0%->5%; Stat Rep: ->RP-240169; Rapporteur: Ericsson->Ajit Nimbalker, Ericsson; Rap eMail: ->Ajit.Nimbalker@ericsson.com;
- 19: 14/3/24: Stat Rep: ->RP-240169; Rapporteur: Ericsson->Ajit Nimbalker, Ericsson; Rap eMail: ->Ajit.Nimbalker@ericsson.com;
- 22: 2/4/24: WID:RP-234056->RP-240801
- 23: 14/3/24: Compl:0%->8%; Stat Rep: ->RP-240134; Rapporteur: vivo->Xueming Pan, vivo; Rap eMail: ->panxueming@vivo.com;
- 24: 14/3/24: Stat Rep: ->RP-240134; Rapporteur: vivo->Xueming Pan, vivo; Rap eMail: ->panxueming@vivo.com;
- 25: -
- 26: 5/4/22: 22.875 added;; 4/6/22: 0%->15; 21/6/22: WID:SP-220083->SP-220439. FS_AIML_Ph2->FS_AIML_MT_Ph2; 13/7/22: 22.876 added;; 10/12/22: 15%->50; 10/12/22: FCD:12/12/2022->06/23; 17/3/23: 50%->75; 8/6/23: 75%->95; 8/6/23: FCD:06/06/2023->09/20; 6/9/23: 95%->100
- 27: ; 6/9/23: 0%->80; 8/12/23: 80%->100
- 28: 14/3/24: 0%->25
- 29: 3/4/24: 33.784 added;
- 31: 8/12/23: 0%->35; 4/1/24: 23.700-82 added;; 14/3/24: 35%->55
- 32: 14/3/24: FCD:06/06/2024->/24; 2/4/24: WID:RP-234054->RP-240323; 3/4/24: 38.743 added;
- 33: 14/3/24: FCD:28/05/2021->12/12/2024; Stat Rep: ->RP-240083; Rapporteur: Oppo->Zhongda Du, OPPO; Rap eMail: ->duzhongda@oppo.com; ; 2/4/24: WID:RP-234055->RP-240082; 3/4/24: 38.744 added;

| ID | WBS | Task | Type | Duration | Start | Finish | Complete | Remaining | Total slack | Constraint | Resources | Work | Actual work | Acronym | PCG approved | Release | TSG approved | Status Report | Impacted TSs and TRs |
| --- | --- | --- | --- | --- | --- | --- | --- | --- | --- | --- | --- | --- | --- | --- | --- | --- | --- | --- | --- |
| 34 | 23 | **Artificial Intelligence (AI)/Machine Learning (ML) for NR air interface** |  | 582d | 2023-12-13 A | 2026-03-03 | 2% | 569.21d | 0d |  |  | 8312h |  | NR_AIML_air | 52 | Rel-19 | 102 |  |  |
| 35 | 23.1 | Core part: Artificial Intelligence (AI)/Machine Learning (ML) for NR air interface |  | 457d | 2023-12-13 A | 2025-09-09 | 5% | 434.15d | 125d | finish no earlier than 2025-09-09 | R1 | 3656h |  | NR_AIML_air-Core | 52 | Rel-19 | 102 | RP-240499 |  |
| 36 | 23.2 | Perf. part: Artificial Intelligence (AI)/Machine Learning (ML) for NR air interface |  | 582d | 2023-12-13 | 2026-03-03 |  |  | 0d | finish no earlier than 2026-03-03 | R4 | 4656h |  | NR_AIML_air-Perf | 52 | Rel-19 | 102 | RP-240499 |  |
| 37 | 24 | Rel-19 Ambient power-enabled Internet of Things | milestone | 0d? | 2016-03-15 A | 2016-03-15 A | 100% |  |  | start no earlier than 2016-03-15 |  |  |  |  |  | Rel-19 |  |  |  |
| 38 | 25 | **Ambient power-enabled Internet of Things** |  | 724d | 2022-03-10 A | 2024-12-12 | 74% | 189.33d | 318d |  |  | 5696h | 3680h | AmbientIoT | 52 | Rel-19 | 102 |  | 22.261 |
| 39 | 25.1 | Study on Ambient power-enabled Internet of Things |  | 460d | 2022-03-10 A | 2023-12-12 A | 100% |  |  | finish no earlier than 2023-12-12 | S1 | 3680h | 3680h | FS_AmbientIoT | 48 | Rel-19 | 95 |  | 22.840 |
| 40 | 25.2 | Study on Architecture support of Ambient power-enabled Internet of Things |  | 248d | 2024-01-04 A | 2024-12-12 | 25% | 186d | 318d | finish no earlier than 2024-12-12 | S2 | 1984h |  | FS_AmbientIoT | 52 | Rel-19 | 102 |  |  |
| 41 | 25.3 | Stage 1 of Ambient power-enabled Internet of Things |  | 4d | 2023-12-07 A | 2023-12-12 | 95% | 0.2d | 582d | finish no earlier than 2023-12-12 | S1 | 32h |  | AmbientIoT | 52 | Rel-19 | 102 |  | 22.261 |
| 42 | 26 | Study on solutions for Ambient IoT (Internet of Things) in NR |  | 264d | 2023-12-13 A | 2024-12-12 | 8% | 242.88d | 318d | finish no earlier than 2024-12-12 | R1 | 2112h |  | FS_Ambient_IoT_solutions | 52 | Rel-19 | 102 | RP-240155 | 38.769 |
| 43 | 27 | Study on Security Aspect of Ambient IoT Services in 5G |  | 183d | 2024-04-02 | 2024-12-12 |  |  | 318d | start no earlier than 2024-04-02 | S3 | 1464h |  | FS_Ambient_IoT_Sec |  | Rel-19 |  |  | 33.713 |
| 44 | 28 | See also IoT_NTN_Ph3 under Satellite/NTN | milestone | 0d? | 2016-03-15 A | 2016-03-15 A | 100% |  |  | start no earlier than 2016-03-15 |  |  |  |  |  | Rel-18 |  |  |  |
| 45 | 29 | Rel-19 Satellite (5GSAT), NTN | milestone | 0d? | 2016-03-15 A | 2016-03-15 A | 100% |  |  | start no earlier than 2016-03-15 |  |  |  |  |  | Rel-19 |  |  |  |
| 46 | 30 | **Satellite access Phase 3** |  | 595d | 2022-06-02 A | 2024-09-06 | 74% | 156.29d | 387d |  |  | 6688h | 3744h | 5GSAT_Ph3 | 51 | Rel-19 | 100 |  | 22.261 |
| 47 | 30.1 | Study on satellite access - Phase 3 |  | 333d | 2022-06-02 A | 2023-09-09 A | 100% |  |  | finish no earlier than 2023-09-09 | S1 | 2664h | 2664h | FS_5GSAT_Ph3 | 49 | Rel-19 | 96 |  |  |
| 48 | 30.2 | Stage 1 of Satellite access Phase 3 |  | 135d | 2023-06-08 A | 2023-12-12 A | 100% |  |  | finish no earlier than 2023-12-12 | S1 | 1080h | 1080h | 5GSAT_Ph3 | 51 | Rel-19 | 100 |  | 22.261 |
| 49 | 30.3 | Study on Integration of satellite components in the 5G architecture Phase 3 |  | 188d | 2023-09-20 A | 2024-06-05 | 55% | 84.6d | 454d | finish no earlier than 2024-06-06 | S2 | 1504h |  | FS_5GSAT_Ph3_ARCH | 51 | Rel-19 | 101 |  | 23.700-29; 28.874 |
| 50 | 30.4 | Study on application enablement for Satellite access enabled 5G Services |  | 180d | 2024-01-03 A | 2024-09-06 | 25% | 135d | 387d | start no earlier than 2024-01-03 | S6 | 1440h |  | FS_5GSAT_Ph3_App | 52 | Rel-19 | 102 |  | 23.700-01 |
| 51 | 31 | Study on Security Aspects of 5G Satellite Access Phase 3 |  | 248d | 2024-01-04 A | 2024-12-12 | 10% | 223.2d | 318d | finish no earlier than 2024-12-12 | S3 | 1984h |  | FS_5GSAT_Ph3_SEC | 52 | Rel-19 | 102 |  | 33.700-29 |
| 52 | 32 | **Non-Terrestrial Networks (NTN) for NR Phase 3** |  | 582d | 2023-12-13 A | 2026-03-03 | 2% | 569.21d | 0d |  |  | 8312h |  | NR_NTN_Ph3 | 52 | Rel-19 | 102 |  |  |
| 53 | 32.1 | Core part: Non-Terrestrial Networks (NTN) for NR Phase 3 |  | 457d | 2023-12-13 A | 2025-09-09 | 5% | 434.15d | 125d | finish no earlier than 2025-09-09 | R2 | 3656h |  | NR_NTN_Ph3-Core | 52 | Rel-19 | 102 | RP-240091 |  |
| 54 | 32.2 | Perf. part: Non-Terrestrial Networks (NTN) for NR Phase 3 |  | 582d | 2023-12-13 | 2026-03-03 |  |  | 0d | finish no earlier than 2026-03-03 | R4 | 4656h |  | NR_NTN_Ph3-Perf | 52 | Rel-19 | 102 | RP-240091 |  |
| 55 | 33 | **Non-Terrestrial Networks (NTN) for Internet of Things (IoT) Phase 3 (for LTE)** |  | 582d | 2023-12-13 | 2026-03-03 |  |  | 0d |  |  | 7848h |  | IoT_NTN_Ph3 | 52 | Rel-19 | 102 |  |  |
| 56 | 33.1 | Core part: Non-Terrestrial Networks (NTN) for Internet of Things (IoT) Phase 3 |  | 457d | 2023-12-13 | 2025-09-09 |  |  | 125d | finish no earlier than 2025-09-09 | R2 | 3656h |  | IoT_NTN_Ph3-Core | 52 | Rel-19 | 102 |  |  |
| 57 | 33.2 | Perf. part: Non-Terrestrial Networks (NTN) for Internet of Things (IoT) Phase 3 |  | 524d | 2024-03-03 | 2026-03-03 |  |  | 0d | finish no earlier than 2026-03-03 | R4 | 4192h |  | IoT_NTN_Ph3-Perf |  | Rel-19 |  |  |  |

Notes:
- 34: 2/4/24: WID:RP-234039->RP-240774 / WI rapporteur name: Qualcomm
- 35: 14/3/24: Compl:0%->5%; Stat Rep: ->RP-240499; Rapporteur: Qualcomm->Juan Montojo (RAN1); Xiaofeng Liu (RAN4); Marco Belleschi (RAN2/RAN3), Qualcomm; CAICT; Ericsson; Rap eMail: ->juanm@qti.qualcomm.com; liuxiaofeng1@caict.ac.cn; marco.belleschi@ericsson.com; / WI rapporteur name: Juan Montojo (RAN1); Xiaofeng Liu (RAN4); Marco Belleschi (RAN2/RAN3), Qualcomm; CAICT; Ericsson / WI rapporteur e-mail: juanm@qti.qualcomm.com; liuxiaofeng1@caict.ac.cn; marco.belleschi@ericsson.com
- 36: 14/3/24: Stat Rep: ->RP-240499; Rapporteur: Qualcomm->Juan Montojo (RAN1); Xiaofeng Liu (RAN4); Marco Belleschi (RAN2/RAN3), Qualcomm; CAICT; Ericsson; Rap eMail: ->juanm@qti.qualcomm.com; liuxiaofeng1@caict.ac.cn; marco.belleschi@ericsson.com; / WI rapporteur name: Juan Montojo (RAN1); Xiaofeng Liu (RAN4); Marco Belleschi (RAN2/RAN3), Qualcomm; CAICT; Ericsson / WI rapporteur e-mail: juanm@qti.qualcomm.com; liuxiaofeng1@caict.ac.cn; marco.belleschi@ericsson.com
- 37: -
- 38: ; 8/12/23: 0%->95 / WI rapporteur name: Xu, Weijie, OPPO / WI rapporteur e-mail: xuweijie@oppo.com
- 39: 5/4/22: 22.840 added;; 4/6/22: 0%->25; 9/9/22: 25%->50; 10/12/22: 50%->65; 17/3/23: 65%->80; 17/3/23: FCD:12/12/2022->/23; 8/6/23: 80%->90; 8/6/23: FCD:03/03/2023->12/20; 6/9/23: 90%->95; 8/12/23: 95%->100 / WI rapporteur name: Rapporteur:Xu, weijie, OPPO / WI rapporteur e-mail: xuweijie@oppo.com
- 40: 14/3/24: 0%->25 / WI rapporteur name: Runze Zhou (Huawei) / WI rapporteur e-mail: zhourunze@huawei.com
- 41: ; 8/12/23: 0%->95 / WI rapporteur name: Xu, Weijie, OPPO / WI rapporteur e-mail: xuweijie@oppo.com
- 42: 14/3/24: Compl:0%->8%; Stat Rep: ->RP-240155; Rapporteur: CMCC->Xiaodong Shen, CMCC; Rap eMail: ->shenxiaodong@chinamobile.com; ; 2/4/24: WID:RP-234058->RP-240826; 3/4/24: 38.769 added; / WI rapporteur name: Xiaodong Shen, CMCC / WI rapporteur e-mail: shenxiaodong@chinamobile.com
- 43: 3/4/24: 33.713 added; / WI rapporteur name: Marcus Wong, / WI rapporteur e-mail: marcus.wong@oppo.com
- 44: -
- 45: -
- 46: ; 6/9/23: 0%->95; 8/12/23: 95%->100 / WI rapporteur name: Rapporteur: Thierry Bérisot, Novamint / WI rapporteur e-mail: tberisot@novamint.com
- 47: 17/8/22: WID:SP-220443->SP-220679; 9/9/22: 0%->35; 10/12/22: 35%->55; 10/12/22: FCD:10/03/2023->06/23; 17/3/23: 55%->80; 8/6/23: 80%->90; 8/6/23: FCD:06/06/2023->09/20; 6/9/23: 90%->100 / WI rapporteur name: Rapporteur: Thierry Bérisot, Novamint / WI rapporteur e-mail: tberisot@novamint.com
- 48: ; 6/9/23: 0%->95; 8/12/23: 95%->100 / WI rapporteur name: Rapporteur: Thierry Bérisot, Novamint / WI rapporteur e-mail: tberisot@novamint.com
- 49: 9/23: company-submitted WID, to be corrected; 6/10/23: 23.700-29 added;; 8/12/23: 0%->15; 4/1/24: 28.874 added;; 14/3/24: 15%->55 / WI rapporteur name: Jean-Yves Fine (Thales) / WI rapporteur e-mail: jean-yves.fine@thalesgroup.com
- 50: 8/12/23: 0%->5; 14/3/24: 0%->25; 2/4/24: WID:SP-231738->SP-240296; 3/4/24: 23.700-01 added; / WI rapporteur name: Basavaraj (Basu) Pattan, Samsung / WI rapporteur e-mail: basavarajjp@samsung.com
- 51: No end date in initial WID SP-231317; 4/1/24: 33.700-29 added;; 14/3/24: 0%->10; 2/4/24: WID:SP-231790->SP-240232 / WI rapporteur name: Zhou Wei / WI rapporteur e-mail: zhouwei@catt.cn
- 52: 2/4/24: WID:RP-234078->RP-240775 / WI rapporteur name: Thales
- 53: 14/3/24: Compl:0%->5%; Stat Rep: ->RP-240091; Rapporteur: Thales->Nicolas Chuberre, Thales; Rap eMail: ->Nicolas.chuberre@thalesaleniaspace.com; / WI rapporteur name: Nicolas Chuberre, Thales / WI rapporteur e-mail: Nicolas.chuberre@thalesaleniaspace.com
- 54: 14/3/24: Stat Rep: ->RP-240091; Rapporteur: Thales->Nicolas Chuberre, Thales; Rap eMail: ->Nicolas.chuberre@thalesaleniaspace.com; / WI rapporteur name: Nicolas Chuberre, Thales / WI rapporteur e-mail: Nicolas.chuberre@thalesaleniaspace.com
- 55: 2/4/24: WID:RP-234077->RP-240776 / WI rapporteur name: Mediatek
- 56: WI rapporteur name: Mediatek
- 57: WI rapporteur name: Mediatek

| ID | WBS | Task | Type | Duration | Start | Finish | Complete | Remaining | Total slack | Constraint | Resources | Work | Actual work | Acronym | WI rapporteur name | Release | PCG approved | Impacted TSs and TRs | WI rapporteur e-mail | TSG approved | Status Report |
| --- | --- | --- | --- | --- | --- | --- | --- | --- | --- | --- | --- | --- | --- | --- | --- | --- | --- | --- | --- | --- | --- |
| 58 | 34 | **Inter-RAT mode mobility support from E-UTRAN TN to NR NTN** |  | 399d | 2024-03-03 | 2025-09-09 |  |  | 125d |  | R2 | 6384h |  | LTE_TN_NR_NTN_mob | Thales | Rel-19 |  |  |  |  |  |
| 59 | 34.1 | Core part: Inter-RAT mode mobility support from E-UTRAN TN to NR NTN |  | 399d | 2024-03-03 | 2025-09-09 |  |  | 125d | finish no earlier than 2025-09-09 | R2 | 3192h |  | LTE_TN_NR_NTN_mob-Core | Thales | Rel-19 |  |  |  |  |  |
| 60 | 35 | **Enhanced requirements and test methodology for NR NTN and IoT NTN** |  | 524d | 2024-03-03 | 2026-03-03 |  |  | 0d |  | R4 | 11576h |  | NR_IoT_NTN_req_test_enh | Samsung | Rel-19 |  |  |  |  |  |
| 61 | 35.1 | Core part: Enhanced requirements and conductive test methodology for NR NTN and IoT NTN |  | 399d | 2024-03-03 | 2025-09-09 |  |  | 125d | finish no earlier than 2025-09-09 | R4 | 3192h |  | NR_IoT_NTN_req_test_enh-Core | Samsung | Rel-19 |  |  |  |  |  |
| 62 | 35.2 | Perf. Part: Enhanced requirements and conductive test methodology for NR NTN and IoT NTN |  | 524d | 2024-03-03 | 2026-03-03 |  |  | 0d | finish no earlier than 2026-03-03 | R4 | 4192h |  | NR_IoT_NTN_req_test_enh-Perf | Samsung | Rel-19 |  |  |  |  |  |
| 63 | 36 | Rel-19 XR (eXtended Reality), Metaverse | milestone | 0d? | 2016-03-15 A | 2016-03-15 A | 100% |  |  | start no earlier than 2016-03-15 |  |  |  |  |  | Rel-19 |  |  |  |  |  |
| 64 | 37 | **Localized Mobile Metaverse Services** |  | 724d | 2022-03-10 A | 2024-12-12 | 65% | 251.08d | 318d |  |  | 7128h | 4224h | Metaverse | Guttman, Erik, Samsung | Rel-19 | 51 | new 22.156, 22.261 ; 22.156 | erik.guttman@samsung.com | 100 |  |
| 65 | 37.1 | Study on Localized Mobile Metaverse Services |  | 393d | 2022-03-10 A | 2023-09-09 A | 100% |  |  | finish no earlier than 2023-09-09 | S1 | 3144h | 3144h | FS_Metaverse | Guttman, Erik, Samsung | Rel-19 | 48 | 22.856 | erik.guttman@samsung.com | 95 |  |
| 66 | 37.2 | Stage 1 of Localized Mobile Metaverse Services |  | 135d | 2023-06-08 A | 2023-12-12 A | 100% |  |  | finish no earlier than 2023-12-12 | S1 | 1080h | 1080h | Metaverse | Guttman, Erik, Samsung | Rel-19 | 51 | new 22.156, 22.261 ; 22.156 | erik.guttman@samsung.com | 100 |  |
| 67 | 37.3 | Study on application enablement for Localized Mobile Metaverse Services |  | 180d | 2024-01-03 A | 2024-09-06 | 30% | 126d | 387d | start no earlier than 2024-01-03 | S6 | 1440h |  | FS_Metaverse_App | Shah, Sapan, Samsung | Rel-19 | 52 | 23.700-21 | sapan.shah@samsung.com | 102 |  |
| 68 | 37.4 | Study on security aspects of 5G Mobile Metaverse services |  | 183d | 2024-04-02 | 2024-12-12 |  |  | 318d | start no earlier than 2024-04-02 | S3 | 1464h |  | FS_Metaverse_Sec | Rohini Rajendran, | Rel-19 |  | 33.721 | r.rohini@samsung.com |  |  |
| 69 | 38 | Study on Extended Reality and Media service (XRM) Phase 2 |  | 113d | 2024-01-03 A | 2024-06-05 | 45% | 62.15d | 454d | start no earlier than 2024-01-03 | S2 | 904h |  | FS_XRM_Ph2 | Primary Rapporteur: Devaki Chandramouli (Nokia) | Rel-19 | 51 | 23.700-70 | devaki.chandramouli@nokia.com. | 101 |  |
| 70 | 39 | Study on Application enabler for XR Services |  | 180d | 2024-01-03 A | 2024-09-06 | 20% | 144d | 387d | start no earlier than 2024-01-03 | S6 | 1440h |  | FS_XRApp | Zheng, Shaowen, CMCC | Rel-19 | 52 | 23.700-23 | zhengshaowen@chinamobile.com | 102 |  |
| 71 | 40 | Supporting UE Mobility for XR Services |  | 59d | 2023-03-16 A | 2023-06-06 A | 100% |  |  | finish no earlier than 2023-06-06 | S1 | 472h | 472h | XRMobility | Xiaonan Shi, ChinaMobile | Rel-19 | 50 | 22.261 | shixiaonan@chinamobile.com | 99 |  |
| 72 | 41 | **XR (eXtended Reality) for NR Phase 3** |  | 582d | 2023-12-13 A | 2026-03-03 | 1% | 576.89d | 0d |  |  | 8312h |  | NR_XR_Ph3 | Nokia | Rel-19 | 52 |  |  | 102 |  |
| 73 | 41.1 | Core part: XR (eXtended Reality) for NR Phase 3 |  | 457d | 2023-12-13 A | 2025-09-09 | 2% | 447.86d | 125d | finish no earlier than 2025-09-09 | R2 | 3656h |  | NR_XR_Ph3-Core | Benoist S bire, Nokia | Rel-19 | 52 |  | benoist.sebire@nokia.com | 102 | RP-240081 |
| 74 | 41.2 | Perf. part: XR (eXtended Reality) for NR Phase 3 |  | 582d | 2023-12-13 | 2026-03-03 |  |  | 0d | finish no earlier than 2026-03-03 | R4 | 4656h |  | NR_XR_Ph3-Perf | Benoist S bire, Nokia | Rel-19 | 52 |  | benoist.sebire@nokia.com | 102 | RP-240081 |
| 75 | 42 | **Indirect Network Sharing** |  | 724d | 2022-03-10 A | 2024-12-12 | 74% | 186.35d | 318d |  |  | 5688h | 4224h |  |  | Rel-19 |  |  |  |  |  |
| 76 | 42.1 | Study on Network Sharing Aspects |  | 393d | 2022-03-10 A | 2023-09-09 A | 100% |  |  | finish no earlier than 2023-09-09 | S1 | 3144h | 3144h | FS_NetShare | Wei, Qun, China Unicom | Rel-19 | 48 | 22.851 | Weiqun5 <at> chinaunicom.cn | 95 |  |
| 77 | 42.2 | (Stage 1 of) Indirect Network Sharing |  | 135d | 2023-06-08 A | 2023-12-12 A | 100% |  |  | finish no earlier than 2023-12-12 | S1 | 1080h | 1080h | NetShare | Wei, Qun, China Unicom | Rel-19 | 51 | 22.261 | Weiqun5 <at> chinaunicom.cn | 100 |  |
| 78 | 42.3 | (Stage 2 of) Indirect Network Sharing |  | 183d | 2024-04-02 | 2024-12-12 |  |  | 318d | start no earlier than 2024-04-02 | S2 | 1464h |  | TEI19_NetShare | Xing, Tianqi, China Unicom, | Rel-19 |  | 23.501; 23.502 | xingtq@chinaunicom.cn |  |  |
| 79 | 43 | **Roaming Value-Added Services** |  | 664d | 2022-06-02 A | 2024-12-12 | 45% | 366.41d | 318d |  |  | 2856h | 1280h |  |  | Rel-19 |  |  |  |  |  |
| 80 | 43.1 | Study on roaming value added services |  | 138d | 2022-06-02 A | 2022-12-12 A | 100% |  |  | finish no earlier than 2022-12-12 | S1 | 1104h | 1104h | FS_RVAS | Peter Bleckert, Ericsson | Rel-19 | 49 | 22.877 |  | 96 |  |
| 81 | 43.2 | Roaming Value-Added Services |  | 22d | 2023-02-02 A | 2023-03-03 A | 100% |  |  | finish no earlier than 2023-03-03 | S1 | 176h | 176h | RVAS | Peter Bleckert, Ericsson | Rel-19 | 50 | 22.261 |  | 99 |  |
| 82 | 43.3 | Architecture support of roaming value-added services |  | 197d | 2024-03-13 | 2024-12-12 |  |  | 318d | finish no earlier than 2024-12-12 | S2 | 1576h |  | TEI19_RVAS | Qian Chen, Ericsson, | Rel-19 |  | 23.501; 23.502 | qian.xb.chen@ericsson.com |  |  |
| 83 | 44 | Rel-19 user plane | milestone | 0d? | 2016-03-15 A | 2016-03-15 A | 100% |  |  | start no earlier than 2016-03-15 |  |  |  |  |  | Rel-19 |  |  |  |  |  |
| 84 | 45 | Video Operating Points - Harmonization and Stereo MV-HEVC |  | 254d | 2024-03-13 | 2025-03-03 |  |  | 261d | start no earlier than 2024-03-13 | S4 | 2032h |  | VOPS | Waqar Zia | Rel-19 |  |  | waqar_zia (at) apple.com |  |  |
| 85 | 46 | Split rendering over IMS |  | 240d | 2024-04-02 | 2025-03-03 |  |  | 261d | start no earlier than 2024-04-02 | S4 | 1920h |  | SR_IMS | He, Shane, Nokia Corporation | Rel-19 |  | 26.264 | shane.he@nokia.com |  |  |
| 86 | 47 | Study on Media Messaging |  | 183d | 2024-04-02 | 2024-12-12 |  |  | 318d | finish no earlier than 2024-12-12 | S4 | 1464h |  | FS_MeMe | Thomas Stockhammer, Qualcomm Incorporated, | Rel-19 |  |  | tsto@qti.qualcomm.com |  |  |
| 87 | 48 | Study on Advanced Media Delivery |  | 183d | 2024-04-02 | 2024-12-12 |  |  | 318d | finish no earlier than 2024-12-12 | S4 | 1464h |  | FS_AMD | Thomas Stockhammer, Qualcomm Incorporated, | Rel-19 |  | 26.802; 26.804 | tsto@qti.qualcomm.com |  |  |
| 88 | 49 | Study of 5G Real-time Transport Protocol Configurations, Phase 2 |  | 183d | 2024-04-02 | 2024-12-12 |  |  | 318d | start no earlier than 2024-04-02 | S4 | 1464h |  | FS_5G_RTP_Ph2 | Igor Curcio, Nokia Corporation | Rel-19 |  |  | igor.curcio@nokia.com |  |  |
| 89 | 50 | Study on Beyond 2D Video |  | 309d | 2024-04-02 | 2025-06-06 |  |  | 192d | start no earlier than 2024-04-02 | S4 | 2472h |  | FS_Beyond2D | Jiayi Xu, | Rel-19 |  |  | xujiayi@chinamobile.com |  |  |
| 90 | 51 | Study on Audio Codec APIs |  | 240d | 2024-04-02 | 2025-03-03 |  |  | 261d | start no earlier than 2024-04-02 | S4 | 1920h |  | FS_ACAPI | Stefan Döhla | Rel-19 |  |  | (stefan DOT doehla AT iis DOT fraunhofer DOT de) |  |  |
| 91 | 52 | Rel-19 Non Public Network | milestone | 0d? | 2016-03-15 A | 2016-03-15 A | 100% |  |  | start no earlier than 2016-03-15 |  |  |  |  |  | Rel-19 |  |  |  |  |  |
| 92 | 53 | Non-Public Network (NPN) security considerations |  | 12d | 2023-05-22 A | 2023-06-06 A | 100% |  |  | start no earlier than 2023-05-22 | S1 | 96h | 96h | SecNPN | Yinglin Chen, China Telecom | Rel-19 | 51 | 22.261 | chenyl37@chinatelecom.cn | 100 |  |
| 93 | 54 | Study on security for PLMN hosting a NPN |  | 180d | 2024-01-03 A | 2024-09-06 | 25% | 135d | 387d | start no earlier than 2024-01-03 | S3 | 1440h |  | PLMNNPN_SEC | Jun Shen | Rel-19 | 52 | 33.757 | shenjun6@chinatelecom.cn | 102 |  |
| 94 | 55 | ProSe support in NPN |  | 197d | 2024-03-13 | 2024-12-12 |  |  | 318d | finish no earlier than 2024-12-12 | S2 | 1576h |  | TEI19_ProSe_NPN | Walter Dees, Philips International B.V., | Rel-19 |  | 23.304; 23.501 | walter.dees@philips.com |  |  |
| 95 | 56 | Rel-19 Other NR and LTE | milestone | 0d? | 2019-03-07 | 2019-03-07 |  |  | 1828d |  |  |  |  |  |  | Rel-18 |  |  |  |  |  |

Notes:
- 63: -
- 64: ; 6/9/23: 0%->80; 21/9/23: 22.156 added;; 8/12/23: 80%->100
- 65: 5/4/22: 22.856 added;; 4/6/22: 0%->15; 9/9/22: 15%->40; 10/12/22: 40%->55; 17/3/23: 55%->75; 8/6/23: 75%->90; 8/6/23: FCD:03/03/2023->09/20; 8/12/23: 90%->100
- 66: ; 6/9/23: 0%->80; 21/9/23: 22.156 added;; 8/12/23: 80%->100
- 67: 8/12/23: 0%->10; 14/3/24: 0%->30; 3/4/24: 23.700-21 added;
- 68: 3/4/24: 33.721 added;
- 69: 9/23: company-submitted WID, to be corrected; 6/10/23: 23.700-70 added;; 8/12/23: 0%->13; 14/3/24: 0%->45
- 70: 8/12/23: 0%->10; 14/3/24: 0%->20; 3/4/24: 23.700-23 added;
- 71: ; 17/3/23: 0%->50; 6/9/23: 50%->100
- 72: 2/4/24: WID:RP-234080->RP-240791
- 73: 14/3/24: Compl:0%->2%; Stat Rep: ->RP-240081; Rapporteur: Nokia->Benoist S bire, Nokia; Rap eMail: ->benoist.sebire@nokia.com;
- 74: 14/3/24: Stat Rep: ->RP-240081; Rapporteur: Nokia->Benoist S bire, Nokia; Rap eMail: ->benoist.sebire@nokia.com;
- 76: 5/4/22: 22.851 added;; 4/6/22: 0%->10; 9/9/22: 10%->20; 10/12/22: 20%->75; 17/3/23: 75%->80; 17/3/23: FCD:12/12/2022->/23; 8/6/23: 80%->95; 8/6/23: FCD:03/03/2023->09/20; 6/9/23: 95%->100
- 77: ; 6/9/23: 0%->100
- 80: 13/7/22: 22.877 added;; 9/9/22: 0%->60; 10/12/22: FCD:10/03/2023->12/22; 10/12/22: 60%->100
- 81: ; 17/3/23: 0%->100
- 83: -
- 91: -
- 93: 4/1/24: 33.757 added;; 14/3/24: 0%->25
- 95: -

| ID | WBS | Task | Type | Duration | Start | Finish | Complete | Remaining | Total slack | Constraint | Resources | Work | Actual work | Acronym | Release | WI rapporteur e-mail | Impacted TSs and TRs | PCG approved | TSG approved | Status Report |
| --- | --- | --- | --- | --- | --- | --- | --- | --- | --- | --- | --- | --- | --- | --- | --- | --- | --- | --- | --- | --- |
| 96 | 57 | **UE RF enhancements for NR FR1/FR2 and EN-DC, Phase 4** |  | 524d | 2024-03-03 | 2026-03-03 |  |  | 0d |  | R4 | 11576h |  | NR_ENDC_RF_Ph4 | Rel-19 |  |  |  |  |  |
| 97 | 57.1 | Core part: UE RF enhancements for NR FR1/FR2 and EN-DC, Phase 4 |  | 399d | 2024-03-03 | 2025-09-09 |  |  | 125d | finish no earlier than 2025-09-09 | R4 | 3192h |  | NR_ENDC_RF_Ph4-Core | Rel-19 |  |  |  |  |  |
| 98 | 57.2 | Perf. part: UE RF enhancements for NR FR1/FR2 and EN-DC, Phase 4 |  | 524d | 2024-03-03 | 2026-03-03 |  |  | 0d | finish no earlier than 2026-03-03 | R4 | 4192h |  | NR_ENDC_RF_Ph4-Perf | Rel-19 |  |  |  |  |  |
| 99 | 58 | **Support of intra-band non-collocated EN-DC/NR-CA deployment Phase2: new receiver type(s)** |  | 524d | 2024-03-03 | 2026-03-03 |  |  | 0d |  | R4 | 11576h |  | NonCol_intraB_ENDC_NR_CA_Ph2 | Rel-19 |  |  |  |  |  |
| 100 | 58.1 | Core part: Support of intra-band non-collocated EN-DC/NR-CA deployment Phase2: new receiver type(s) |  | 399d | 2024-03-03 | 2025-09-09 |  |  | 125d | finish no earlier than 2025-09-09 | R4 | 3192h |  | NonCol_intraB_ENDC_NR_CA_Ph2-Core | Rel-19 |  |  |  |  |  |
| 101 | 58.2 | Perf. part: Support of intra-band non-collocated EN-DC/NR-CA deployment Phase2: new receiver type(s) |  | 524d | 2024-03-03 | 2026-03-03 |  |  | 0d | finish no earlier than 2026-03-03 | R4 | 4192h |  | NonCol_intraB_ENDC_NR_CA_Ph2-Perf | Rel-19 |  |  |  |  |  |
| 102 | 59 | **TRP (Total Radiated Power), TRS (Total Radiated Sensitivity) and MIMO OTA (Over the Air) testing enhancement Phase 3** |  | 524d | 2024-03-03 | 2026-03-03 |  |  | 0d |  | R4 | 11576h |  | TRP_TRS_MIMO_OTA_Ph3 | Rel-19 |  |  |  |  |  |
| 103 | 59.1 | Core part: TRP (Total Radiated Power), TRS (Total Radiated Sensitivity) and MIMO OTA (Over the Air) testing enhancement Phase 3 |  | 399d | 2024-03-03 | 2025-09-09 |  |  | 125d | finish no earlier than 2025-09-09 | R4 | 3192h |  | TRP_TRS_MIMO_OTA_Ph3-Core | Rel-19 |  |  |  |  |  |
| 104 | 59.2 | Perf. part: TRP (Total Radiated Power), TRS (Total Radiated Sensitivity) and MIMO OTA (Over the Air) testing enhancement Phase 3 |  | 524d | 2024-03-03 | 2026-03-03 |  |  | 0d | finish no earlier than 2026-03-03 | R4 | 4192h |  | TRP_TRS_MIMO_OTA_Ph3-Perf | Rel-19 |  |  |  |  |  |
| 105 | 60 | Rel-19 other topics | milestone | 0d? | 2016-03-15 A | 2016-03-15 A | 100% |  |  | start no earlier than 2016-03-15 |  |  |  |  | Rel-19 |  |  |  |  |  |
| 106 | 61 | AKMA service disabling in roaming |  | 22d | 2024-02-02 A | 2024-03-03 A | 100% |  |  | start no earlier than 2024-02-02 | S3 | 176h | 176h | AKMA_Disable | Rel-18 | saurabh.khare@nokia.com |  |  |  |  |
| 107 | 62 | On-demand broadcast of GNSS assistance data |  | 183d | 2024-04-02 | 2024-12-12 |  |  | 318d | start no earlier than 2024-04-02 | S2 | 1464h |  | TEI19_OBGAD | Rel-19 | <liaihua@chinamobile.com> | 23.502; 23.273 |  |  |  |
| 108 | 63 | Minimize the Number of Policy Associations |  | 197d | 2024-03-13 | 2024-12-12 |  |  | 318d | finish no earlier than 2024-12-12 | S2 | 1576h |  | TEI19_MINPA | Rel-19 | belen . pancorbo {@} ericsson . com) | 23.502; 23.501; 23.503 |  |  |  |
| 109 | 64 | Enhancing Parameter Provisioning with static UE IP address and UP security policy |  | 197d | 2024-03-13 | 2024-12-12 |  |  | 318d | finish no earlier than 2024-12-12 | S2 | 1576h |  | TEI19_IP_SP_EXP | Rel-19 | stefan . rommer @ ericsson . com) | 23.501; 23.502 |  |  |  |
| 110 | 65 | Multiple Location Procedure for Emergency LCS Routing |  | 197d | 2024-03-13 | 2024-12-12 |  |  | 318d | finish no earlier than 2024-12-12 | S2 | 1576h |  | TEI19_MLR4RTR | Rel-19 | Simon<dot>Ca<at> nokia<dash>sbell<dot>com | 23.273 |  |  |  |
| 111 | 66 | Roaming traffic offloading via session breakout in HPLMN |  | 183d | 2024-04-02 | 2024-12-12 |  |  | 318d | start no earlier than 2024-04-02 | S2 | 1464h |  | TEI19_HSBO | Rel-19 | hs1207.kim@samsung.com | 23.501 |  |  |  |
| 112 | 67 | Deferred 5GC-MT-LR Procedure for Periodic Location Events based NRPPa Periodic Measurement Reports |  | 197d | 2024-03-13 | 2024-12-12 |  |  | 318d | finish no earlier than 2024-12-12 | S2 | 1576h |  | TEI19_DLPMR | Rel-19 | richard.batorfi@ericsson.com | 23.273 |  |  |  |
| 113 | 68 | QoS monitoring enhancement |  | 183d | 2024-04-02 | 2024-12-12 |  |  | 318d | start no earlier than 2024-04-02 | S2 | 1464h |  | TEI19_QME | Rel-19 | <liaihua@chinamobile.com> | 23.501; 23.502 |  |  |  |
| 114 | 69 | Subscription control for reference time distribution in EPS |  | 197d | 2024-03-13 | 2024-12-12 |  |  | 318d | finish no earlier than 2024-12-12 | S2 | 1576h |  | TEI19_TIME_SUB_EPS | Rel-19 | speicher AT qti DOT qualcomm DOT com) | 23.401 |  |  |  |
| 115 | 70 | Providing per-subscriber VLAN instructions from UDM and DN-AAA |  | 197d | 2024-03-13 | 2024-12-12 |  |  | 318d | finish no earlier than 2024-12-12 | S2 | 1576h |  | TEI19_VLANSUB | Rel-19 | stefan . rommer @ ericsson . com) | 23.501; 23.502 |  |  |  |
| 116 | 71 | NF discovery and selection by target PLMN |  | 183d | 2024-04-02 | 2024-12-12 |  |  | 318d | start no earlier than 2024-04-02 | S2 | 1464h |  | TEI19_NFsel_by_tPLMN | Rel-19 | thomas (dot) belling (at) nokia (dot) com | 23.501; 23.502 |  |  |  |
| 117 | 72 | **Integrated Sensing and Communication** |  | 656d | 2022-03-10 A | 2024-09-09 | 73% | 179.57d | 386d |  |  | 5816h | 4224h | Sensing | Rel-19 | vasil.aleksiev@magenta.at | 22.137 | 51 | 100 |  |
| 118 | 72.1 | Study on Integrated Sensing and Communication |  | 393d | 2022-03-10 A | 2023-09-09 A | 100% |  |  | finish no earlier than 2023-09-09 | S1 | 3144h | 3144h | FS_Sensing | Rel-19 | Vasil.Aleksiev@magenta.at | 22.837 | 48 | 95 |  |
| 119 | 72.2 | Study on Sensing application enabler for vertical applications |  | 199d | 2023-12-08 | 2024-09-09 |  |  | 386d | finish no earlier than 2024-09-09 | S6 | 1592h |  | FS_SensingAPP | Rel-19 | yangyanmei@huawei.com |  | 52 | 102 |  |
| 120 | 72.3 | Stage 1 of Integrated Sensing and Communication |  | 135d | 2023-06-08 A | 2023-12-12 A | 100% |  |  | finish no earlier than 2023-12-12 | S1 | 1080h | 1080h | Sensing | Rel-19 | vasil.aleksiev@magenta.at | 22.137 | 51 | 100 |  |
| 121 | 73 | Study on channel modelling for Integrated Sensing And Communication (ISAC) for NR |  | 390d | 2023-12-13 A | 2025-06-06 | 6% | 366.6d | 192d | finish no earlier than 2025-06-06 | R1 | 3120h |  | FS_Sensing_NR | Rel-19 | liyingyang@xiaomi.com, jerome.vogedes@att.com |  | 52 | 102 | RP-240114 |

Notes:
- 96: WI rapporteur name: Huawei
- 97: WI rapporteur name: Huawei
- 98: WI rapporteur name: Huawei
- 99: WI rapporteur name: KDDI
- 100: WI rapporteur name: KDDI
- 101: WI rapporteur name: KDDI
- 102: WI rapporteur name: Vivo
- 103: WI rapporteur name: Vivo
- 104: WI rapporteur name: Vivo
- 105: -
- 106: 15/3/24: 0%->100 / WI rapporteur name: Khare, Saurabh
- 107: WI rapporteur name: Aihua Li, China Mobile
- 108: WI rapporteur name: Ericsson, Belen Pancorbo
- 109: WI rapporteur name: Stefan Rommer, Ericsson
- 110: WI rapporteur name: Simon Cai (Nokia Shanghai-Bell)Simon<dot>Ca<at> nokia<dash>sbell<dot>com
- 111: WI rapporteur name: Hyesung Kim, Samsung
- 112: WI rapporteur name: Richard, Batorfi, Ericsson,
- 113: WI rapporteur name: Aihua Li, China Mobile
- 114: WI rapporteur name: Sebastian Speicher, Qualcomm
- 115: WI rapporteur name: Stefan Rommer, Ericsson
- 116: WI rapporteur name: Dr. Thomas Belling, Nokia,
- 117: 6/9/23: 0%->80; 8/12/23: 80%->100 / WI rapporteur name: Aleksiev, Vasil, Deutsche Telekom AG
- 118: 5/4/22: 22.837 added;; 4/6/22: 0%->10; 21/6/22: WID:SP-220084->SP-220717; 9/9/22: 10%->40; 10/12/22: 40%->65; 17/3/23: 65%->80; 8/6/23: 80%->90; 8/6/23: FCD:06/06/2023->09/20; 6/9/23: 90%->100 / WI rapporteur name: Aleksiev, Vasil, Deutsche Telekom
- 119: WI rapporteur name: Yanmei Yang, Huawei
- 120: 6/9/23: 0%->80; 8/12/23: 80%->100 / WI rapporteur name: Aleksiev, Vasil, Deutsche Telekom AG
- 121: 14/3/24: Compl:0%->6%; Stat Rep: ->RP-240114; Rapporteur: Xiaomi->Yingyang Li, Jerome Vogedes, Xiaomi, AT&T; Rap eMail: ->liyingyang@xiaomi.com, jerome.vogedes@att.com; ; 2/4/24: WID:RP-234069->RP-240799 / WI rapporteur name: Yingyang Li, Jerome Vogedes, Xiaomi, AT&T

| ID | WBS | Task | Duration | Start | Finish | Complete | Remaining | Total slack | Constraint | Resources | Work | Actual work | Acronym | PCG approved | WI rapporteur name | WI rapporteur e-mail | Release | TSG approved |
| --- | --- | --- | --- | --- | --- | --- | --- | --- | --- | --- | --- | --- | --- | --- | --- | --- | --- | --- |
| 122 | 74 | **Uncrewed Aerial System Phase 3** | 664d | 2022-06-02 A | 2024-12-12 | 60% | 265.9d | 318d |  |  | 8776h | 3744h | UAS_Ph3 | 51 | Pengtai Qin , China Mobile | qinpengtai@chinamobile.com | Rel-19 | 100 |
| 123 | 74.1 | Study on (Stage 1 of) UAV Phase 3 | 333d | 2022-06-02 A | 2023-09-09 A | 100% |  |  | finish no earlier than 2023-09-09 | S1 | 2664h | 2664h | FS_UAV_Ph3 | 49 | Pengtai Qin , China Mobile | qinpengtai@chinamobile.com | Rel-19 | 96 |
| 124 | 74.2 | Study on (Stage 2 of) Phase 3 for UAS, UAV and UAM | 113d | 2024-01-04 A | 2024-06-06 | 50% | 56.5d | 453d | finish no earlier than 2024-06-06 | S2 | 904h |  | FS_UAS_Ph3 | 52 | LaeYoung Kim (LG Electronics) | laeyoung.kim@lge.com | Rel-19 | 102 |
| 125 | 74.3 | Stage 1 of Uncrewed Aerial System Phase 3 | 135d | 2023-06-08 A | 2023-12-12 A | 100% |  |  | finish no earlier than 2023-12-12 | S1 | 1080h | 1080h | UAS_Ph3 | 51 | Pengtai Qin , China Mobile | qinpengtai@chinamobile.com | Rel-19 | 100 |
| 126 | 74.4 | Application Architecture for UAS applications Phase 3 | 333d | 2023-09-07 A | 2024-12-11 | 40% | 199.8d | 319d | finish no earlier than 2024-12-12 | S6 | 2664h |  | UASAPP_Ph3 | 51 | Monrad, Atle, InterDigital | <atle.monrad@interdigital.com> | Rel-19 | 101 |
| 127 | 74.5 | UAS security enhancements | 183d | 2024-04-02 | 2024-12-12 |  |  | 318d | start no earlier than 2024-04-02 | S3 | 1464h |  | FS_UAS_Ph3_Sec |  | Markus Hanhisalo, | markus.hanhisalo@ericsson.com | Rel-19 |  |
| 128 | 75 | Study on Upper layer traffic steering, switching and split over dual 3GPP access | 333d | 2022-06-02 A | 2023-09-09 A | 100% |  |  | finish no earlier than 2023-09-09 | S1 | 2664h | 2664h | FS_DualSteer | 49 | Francesco Pica; Qualcomm |  | Rel-19 | 96 |
| 129 | 76 | Upper layer traffic steering and switching over dual 3GPP access | 4d | 2023-12-07 A | 2023-12-12 | 95% | 0.2d | 582d | finish no earlier than 2023-12-12 | S1 | 32h |  | DualSteer | 52 | Pica Francesco, Qualcomm | fpica<at>qti.qualcomm.com | Rel-19 | 102 |
| 130 | 77 | Study on Multi-Access (DualSteer and ATSSS_Ph4) | 113d | 2024-01-04 A | 2024-06-06 | 30% | 79.1d | 453d | finish no earlier than 2024-06-06 | S2 | 904h |  | FS_MASSS | 52 | Krisztian Kiss (Apple) | krisztian@apple.com | Rel-19 | 102 |
| 131 | 78 | Study on security aspects for Multi-Access (DualSteer + ATSSS Ph-4) | 183d | 2024-04-02 | 2024-12-12 |  |  | 318d | start no earlier than 2024-04-02 | S3 | 1464h |  | FS_MASSS_Sec |  | Kolekar, Abhijeet (Intel) | abhijeet.kolekar@intel.com | Rel-19 |  |
| 132 | 79 | Edge Computing Considering the Operational Needs of Service Hosting Environment | 16d | 2023-08-21 A | 2023-09-09 A | 100% |  |  | start no earlier than 2023-08-21 | S1 | 128h | 128h | EdgeOpNeeds | 51 | Yuying Zhang, China Telecom | zhangyy45@chinatelecom.cn | Rel-19 | 101 |
| 133 | 80 | Study on Enhancement of support for Edge Computing in 5G Core network - Phase 3 | 113d | 2024-01-04 A | 2024-06-06 | 50% | 56.5d | 453d | finish no earlier than 2024-06-06 | S2 | 904h |  | FS_eEDGE_5GC_Ph3 | 52 | Changhong Shan (Intel) | chang.hong.shan@intel.com | Rel-19 | 102 |
| 134 | 81 | Study on Security Aspects of Enhancement of Support for Edge Computing in 5GC phase 3 | 183d | 2024-04-02 | 2024-12-12 |  |  | 318d | finish no earlier than 2024-12-12 | S3 | 1464h |  | FS_EDGE_Ph3 |  | Ge Yao, | yaog9@chinaunicom.cn | Rel-19 |  |
| 135 | 82 | Study on System aspects of 5G NR Femto | 113d | 2024-01-04 A | 2024-06-06 | 40% | 67.8d | 453d | finish no earlier than 2024-06-06 | S2 | 904h |  | FS_5G_Femto | 52 | Malla Reddy Sama (NTT DOCOMO) | sama@docomolab-euro.com | Rel-19 | 102 |
| 136 | 83 | Study on security aspects of 5G NR Femto Document for: Approval | 183d | 2024-04-02 | 2024-12-12 |  |  | 318d | start no earlier than 2024-04-02 | S3 | 1464h |  | FS_5G_Femto_Sec |  | Peilin LIU (ZTE) | liu.peilin@zte.com.cn , | Rel-19 |  |
| 137 | 84 | Study on Proximity-based Services in 5GS Phase 3 | 113d | 2024-01-04 A | 2024-06-06 | 45% | 62.15d | 453d | finish no earlier than 2024-06-06 | S2 | 904h |  | FS_5G_ProSe_Ph3 | 52 | Hugh Shieh (AT&T) | hs6220@att.com | Rel-19 | 102 |
| 138 | 85 | Study on Security Aspects of Enhancement for Proximity Based Services in 5GS Phase 3 | 183d | 2024-04-02 | 2024-12-12 |  |  | 318d | start no earlier than 2024-04-02 | S3 | 1464h |  | FS_5G_ProSe_Ph3_SEC |  | Lei, Ao (Huawei) | leiao@huawei.com | Rel-19 |  |
| 139 | 86 | Study on Vehicle Mounted Relays Phase 2 | 113d | 2024-01-04 A | 2024-06-06 | 40% | 67.8d | 453d | finish no earlier than 2024-06-06 | S2 | 904h |  | FS_VMR_Ph2 | 52 | Primary Rapporteur: Hong Cheng (Qualcomm) | hongc@qti.qualcomm.com | Rel-19 | 102 |
| 140 | 87 | Study on User Identities and Authentication Architecture | 113d | 2024-01-04 A | 2024-06-06 | 35% | 73.45d | 453d | finish no earlier than 2024-06-06 | S2 | 904h |  | FS_UIA_ARC | 52 | Michael Starsinic, Interdigital | Michael.Starsinic@Interdigital.com | Rel-19 | 102 |
| 141 | 88 | Study on security aspects of User Identities and Authentication | 183d | 2024-04-02 | 2024-12-12 |  |  | 318d | start no earlier than 2024-04-02 | S3 | 1464h |  | FS_UIA_Sec |  | Samir Ferdi, | Samir.Ferdi@InterDigital.com | Rel-19 |  |
| 142 | 89 | Study on FRMCS Phase 5 | 460d | 2022-03-10 A | 2023-12-12 A | 100% |  |  | finish no earlier than 2023-12-12 | S1 | 3680h | 3680h | FS_FRMCS_Ph5 | 48 | Patrick WIMART, UIC | wimart@uic.org | Rel-19 | 95 |
| 143 | 90 | FRMCS Phase 5 | 135d | 2023-06-08 A | 2023-12-12 A | 100% |  |  | finish no earlier than 2023-12-12 | S1 | 1080h | 1080h | FRMCS_Ph5 | 51 | Nikolopoulou, Vassiliki, UIC | nikolopoulou@uic.org | Rel-19 | 100 |
| 144 | 91 | Study on Supporting of Railway Smart Station Services | 776d | 2019-09-19 A | 2022-09-08 A | 100% |  |  | finish no earlier than 2022-09-08 | S1 | 6208h | 6208h | FS_RAILSS | 43 | Han, Andrew Min-gyu, Hansung University | andyhan(at)hansung(dot)ac(dot)kr | Rel-19 | 85 |
| 145 | 92 | Study on UPF enhancement for Exposure And SBA Phase 2 | 113d | 2024-01-04 A | 2024-06-06 | 45% | 62.15d | 453d | finish no earlier than 2024-06-06 | S2 | 904h |  | FS_UPEAS_Ph2 | 52 | Zhu Jinguo, ZTE | zhu.jinguo@zte.com.cn | Rel-19 | 102 |
| 146 | 93 | Study on Network of Service Robots with Ambient Intelligence | 400d | 2022-06-02 A | 2023-12-12 A | 100% |  |  | finish no earlier than 2023-12-12 | S1 | 3200h | 3200h | FS_SOBOT | 49 | LEE, Ki-Dong, LG Electronics | kidong.lee@lge.com | Rel-19 | 96 |
| 147 | 94 | Study on Interconnect of SNPN | 323d | 2023-03-16 A | 2024-06-05 | 65% | 113.05d | 454d | finish no earlier than 2024-06-06 | S1 | 2584h |  | FS_ISN | 50 | Thierry Bérisot, Novamint | tberisot@novamint.com | Rel-19 | 99 |
| 148 | 95 | Interconnect of SNPN | 13d | 2024-03-13 A | 2024-03-29 A | 100% |  |  | finish no earlier than 2024-03-29 | S1 | 104h | 104h | ISN |  | Thierry Bérisot, Novamint, | tberisot@novamint.com | Rel-19 |  |
| 149 | 96 | Edge Computing for Industrial Scenarios | 22d | 2023-02-02 A | 2023-03-03 A | 100% |  |  | finish no earlier than 2023-03-03 | S1 | 176h | 176h | EDGINDUS | 50 | Bruno Tossou, Orange | bruno.tossou@orange.com | Rel-19 | 99 |
| 150 | 97 | PS Data Off for IMS Data Channel Service | 22d | 2023-02-02 A | 2023-03-03 A | 100% |  |  | finish no earlier than 2023-03-03 | S1 | 176h | 176h | IMSDCDataOff | 50 | Yue Hu, China Mobile | huyueyjy@chinamobile.com | Rel-19 | 99 |
| 151 | 98 | Study on system architecture for next generation real time communication services phase 2 | 188d | 2023-09-20 A | 2024-06-05 | 45% | 103.4d | 454d | finish no earlier than 2024-06-06 | S2 | 1504h |  | FS_NG_RTC_Ph2 | 51 | Yi Jiang (China Mobile) | jiangyi@chinamobile.com | Rel-19 | 101 |
| 152 | 99 | Multi-path relay | 13d | 2022-09-01 A | 2022-09-19 A | 100% |  |  | start no earlier than 2022-09-01 | S1 | 104h | 104h | MultiRelay | 49 | Yuying Zhang, China Telecom | zhangyy45@chinatelecom.cn | Rel-19 | 97 |
| 153 | 100 | UE-to-UE multi-hop relay | 12d | 2023-05-22 A | 2023-06-06 A | 100% |  |  | start no earlier than 2023-05-22 | S1 | 96h | 96h | UEMHopRelay | 51 | Lipford, Mark, FirstNet Authority, | mark.lipford@firstnet.gov | Rel-19 | 100 |
| 154 | 101 | Interworking of Non-3GPP Digital Terrestrial Broadcast Networks with 5GS Multicast Broadcast Services | 13d | 2022-09-01 A | 2022-09-19 A | 100% |  |  | start no earlier than 2022-09-01 | S1 | 104h | 104h | DTT4MBS | 49 | Saha, Anindya, Saankhya Labs | anindya@saankhyalabs.com | Rel-19 | 97 |
| 155 | 102 | MPS for Messaging services | 13d | 2022-09-01 A | 2022-09-19 A | 100% |  |  | start no earlier than 2022-09-01 | S1 | 104h | 104h | MPS4msg | 49 | Singh, Ray, Peraton Labs | rsingh@peratonlabs.com | Rel-19 | 97 |
| 156 | 103 | Study on MPS for IMS Messaging and SMS services | 113d | 2024-01-03 A | 2024-06-05 | 70% | 33.9d | 454d | start no earlier than 2024-01-03 | S2 | 904h |  | FS_MPS4msg | 51 | Robert Streijl (Peraton Labs) | rstreijl@peratonlabs.com | Rel-19 | 101 |
| 157 | 104 | Minimization of Service Interruption During Core Network Failure Phase 2 | 13d | 2022-09-01 A | 2022-09-19 A | 100% |  |  | finish no earlier than 2022-09-19 | S1 | 104h | 104h | MINT_Ph2 | 49 | Yinglin Chen, China Telecom | chenyl37@chinatelecom.cn | Rel-19 | 97 |
| 158 | 105 | Measurement Data Collection | 8d | 2022-12-09 A | 2022-12-20 A | 100% |  |  | finish no earlier than 2022-12-20 | S1 | 64h | 64h | MeasureData | 50 | Yingjun Zhou, ZTE Corporation | zhou.yingjun@zte.com.cn | Rel-19 | 98 |
| 159 | 106 | Local traffic routing for multi-access UE | 16d | 2023-08-21 A | 2023-09-09 A | 100% |  |  | start no earlier than 2023-08-21 | S1 | 128h | 128h | LTR_MA | 51 | Yinglin Chen, China Telecom | chenyl37@chinatelecom.cn | Rel-19 | 101 |
| 160 | 107 | Study on Diverse audio Capturing system for End-user Devices | 460d | 2022-12-13 A | 2024-09-11 | 70% | 138d | 384d | finish no earlier than 2024-09-12 | S4 | 3680h |  | FS_DaCED | 50 | Wang Bin, Xiaomi | wangbin23@xiaomi.com | Rel-19 | 98 |
| 161 | 108 | Study on Service aspects for supporting the eMMTel service | 330d | 2023-06-08 A | 2024-09-06 | 35% | 214.5d | 387d | finish no earlier than 2024-09-09 | S6 | 2640h |  | FS_eMMTelAPP | 51 | Liu, Yue, China Mobile | liuyueyjy@chinamobile.com | Rel-19 | 100 |
| 162 | 109 | Study on enhanced application layer support for location services | 331d | 2023-06-08 A | 2024-09-09 | 40% | 198.6d | 386d | finish no earlier than 2024-09-09 | S6 | 2648h |  | FS_eLSAPP | 51 | Liping Wu, CATT | wuliping@cictmobile.com | Rel-19 | 100 |
| 163 | 110 | Sharing of administrative configuration between interconnected MC service systems | 398d | 2023-06-08 A | 2024-12-11 | 90% | 39.8d | 319d | finish no earlier than 2024-12-12 | S6 | 3184h |  | MCShAC | 51 | andreas.flander@bdbos.bund.de | andreas.flander@bdbos.bund.de | Rel-19 | 100 |
| 164 | 111 | 5GMSG Service phase 3 | 330d | 2023-06-08 A | 2024-09-06 | 35% | 214.5d | 387d | finish no earlier than 2024-09-09 | S6 | 2640h |  | 5GMARCH_Ph3 | 51 | Liu, Yue, China Mobile, | liuyueyjy@chinamobile.com | Rel-19 | 100 |
| 165 | 112 | Security aspects for MSGin5G Service Phase 3 | 183d | 2024-04-02 | 2024-12-12 |  |  | 318d | start no earlier than 2024-04-02 | S3 | 1464h |  | 5GMARCH_SEC_Ph3 |  | Xiaoting Huang, | huangxiaoting@chinamobile.com | Rel-19 |  |
| 166 | 113 | Railways specific Enhancements to Mission Critical Services | 398d | 2023-06-08 A | 2024-12-11 | 40% | 238.8d | 319d | finish no earlier than 2024-12-12 | S6 | 3184h |  | enh4FRMCS | 51 | Oettl, Martin, Nokia, | martin.oettl@nokia.com | Rel-19 | 100 |
| 167 | 114 | Enhanced Mission Critical Architecture | 398d | 2023-06-08 A | 2024-12-11 | 40% | 238.8d | 319d | finish no earlier than 2024-12-12 | S6 | 3184h |  | enhMC | 51 | Negalaguli, Harish, Motorola Solutions, | harish.negalaguli@motorolasolutions.com | Rel-19 | 100 |
| 168 | 115 | SEAL DD (Data Delivery) Phase 2 | 333d | 2023-09-07 A | 2024-12-11 | 35% | 216.45d | 319d | finish no earlier than 2024-12-12 | S6 | 2664h |  | SEALDD_Ph2 | 51 | Cuili Ge, Huawei | gecuili@huawei.com | Rel-19 | 101 |
| 169 | 116 | Architecture for enabling Edge Applications Phase 3 | 333d | 2023-09-07 A | 2024-12-11 | 35% | 216.45d | 319d | finish no earlier than 2024-12-12 | S6 | 2664h |  | EDGEAPP_Ph3 | 51 | Hyesung Kim, Samsung | hs1207.kim@samsung.com | Rel-19 | 101 |
| 170 | 117 | Guidelines for CAPIF Usage | 265d | 2023-09-07 A | 2024-09-06 | 55% | 119.25d | 387d | finish no earlier than 2024-09-09 | S6 | 2120h |  | CAPIF_EXT | 51 | Junpei Uoshima, NTT DOCOMO | junpei.uoshima.mt@nttdocomo.com | Rel-19 | 101 |
| 171 | 118 | Study on CAPIF Phase 3 | 180d | 2024-01-04 A | 2024-09-09 | 20% | 144d | 386d | finish no earlier than 2024-09-09 | S6 | 1440h |  | FS_CAPIF_Ph3 | 52 | Preciado Rojas, Diego, Nokia | diego.preciado_rojas@nokia.com | Rel-19 | 102 |
| 172 | 119 | Rel-19 miscellaneous Security | 1d | 2019-03-07 | 2019-03-07 |  |  | 1827d |  |  |  |  |  |  |  |  | Rel-19 |  |
| 173 | 120 | Security Assurance Specification for maintenance of 5G features | 240d | 2024-04-02 | 2025-03-03 |  |  | 261d | start no earlier than 2024-04-02 | S3 | 1920h |  | SCAS_5G_Maint |  | Rong Wu (Huawei) | raina.wu@huawei.com | Rel-19 |  |
| 174 | 121 | 5G Security Assurance Specification (SCAS) for the Unified Data Repository (UDR) | 266d | 2023-09-06 A | 2024-09-06 | 10% | 239.4d | 387d | start no earlier than 2023-09-06 | S3 | 2128h |  | SCAS_5G_UDR | 51 | Andreas, Joerg, BSI Germany | joerg.andreas@bsi.bund.de | Rel-19 | 101 |
| 175 | 122 | 5G Security Assurance Specification (SCAS) for the Short Message Service Function (SMSF) | 266d | 2023-09-06 A | 2024-09-06 | 40% | 159.6d | 387d | finish no earlier than 2024-09-09 | S3 | 2128h |  | SCAS_5G_SMSF | 51 | Manjesh K. Hanawal, IIT Bombay | mhanawal@iitb.ac.in | Rel-19 | 101 |
| 176 | 123 | Addition of 256-bit security Algorithms | 130d | 2023-09-06 A | 2024-03-03 A | 100% |  |  | finish no earlier than 2024-03-03 | S3 | 1040h | 1040h | 256_Algo | 51 | Orkopoulos, Stawros | stawros.orkopoulos@nokia.com | Rel-19 | 101 |
| 177 | 124 | Addition of Milenage-256 algorithm | 248d | 2024-01-03 A | 2024-12-11 | 5% | 235.6d | 319d | start no earlier than 2024-01-03 | S3 | 1984h |  | Milenage_256 | 52 | Mireille Pauliac | mireille.pauliac@thalesgroup.com | Rel-19 | 102 |
| 178 | 125 | Study on enabling a cryptographic algorithm transition to 256-bits | 248d | 2024-01-03 A | 2024-12-11 | 10% | 223.2d | 319d | start no earlier than 2024-01-03 | S3 | 1984h |  | FS_CAT256 | 52 | Yuto Nakano | yt-nakano@kddi.com | Rel-19 | 102 |
| 179 | 126 | Study on enablers for Zero Trust Security | 248d | 2024-01-03 A | 2024-12-11 | 20% | 198.4d | 319d | start no earlier than 2024-01-03 | S3 | 1984h |  | FS_eZTS | 52 | Sheeba Backia Mary Baskaran | smary@lenovo.com | Rel-19 | 102 |
| 180 | 127 | Mission critical security enhancements for release 19 | 248d | 2024-01-04 A | 2024-12-12 | 10% | 223.2d | 318d | finish no earlier than 2024-12-12 | S3 | 1984h |  | MCXSec4 | 52 | Woodward, Tim, Motorola Solutions, Inc. | tim.woodward@motorolasolutions.com | Rel-19 | 102 |
| 181 | 128 | Study on the security support for the Next Generation Real Time Communication services phase 2 | 248d | 2024-01-03 A | 2024-12-11 | 17% | 205.84d | 319d | start no earlier than 2024-01-03 | S3 | 1984h |  | FS_NG_RTC_SEC_Ph2 | 52 | Vlasios Tsiatsis | vlasios.tsiatsis@ericsson.com | Rel-19 | 102 |
| 182 | 129 | Study of ACME for Automated Certificate Management in SBA | 113d | 2024-01-03 A | 2024-06-05 | 15% | 96.05d | 454d | start no earlier than 2024-01-03 | S3 | 904h |  | FS_ACME_SBA | 52 | Charles Eckel | eckelcu(at)cisco.com | Rel-19 | 102 |
| 183 | 130 | 3GPP profiles for cryptographic algorithms and security protocols | 248d | 2024-01-03 A | 2024-12-11 | 20% | 198.4d | 319d | start no earlier than 2024-01-03 | S3 | 1984h |  | CryptoSP | 52 | Mohsin Khan A | mohsin.a.khan@ericsson.com | Rel-19 | 102 |
| 184 | 131 | Study on mitigations against bidding down attacks | 113d | 2024-01-03 A | 2024-06-05 | 20% | 90.4d | 454d | start no earlier than 2024-01-03 | S3 | 904h |  | FS_MiBiDA | 52 | Noamen Ben Henda | noamen.ben.henda@huawei.com | Rel-19 | 102 |
| 185 | 132 | Security for mobility over non-3GPP access to avoid full primary authentication | 248d | 2024-01-03 A | 2024-12-11 | 25% | 186d | 319d | start no earlier than 2024-01-03 | S3 | 1984h |  | FS_Non3GPPMob_Sec | 52 | Saurabh Khare, Nokia | Saurabh.Khare@nokia.com | Rel-19 | 102 |
| 186 | 133 | Rel-19 miscellaneous OAM&charging | 1d | 2019-03-07 | 2019-03-07 |  |  | 1827d |  |  |  |  |  |  |  |  | Rel-19 |  |
| 187 | 134 | Study on Management Data Analytics (MDA) Phase 3 | 180d | 2024-01-03 | 2024-09-06 |  |  | 387d | start no earlier than 2024-01-03 | S5 | 1440h |  | FS_eMDAS_Ph3 | 52 | Brendan T Hassett (Huawei) | brendan.t.hassett@huawei.com | Rel-19 | 102 |
| 188 | 135 | Study on intent driven management services for mobile network phase 3 | 180d | 2024-01-03 A | 2024-09-06 | 5% | 171d | 387d | start no earlier than 2024-01-03 | S5 | 1440h |  | FS_IDMS_MN_Ph3 | 52 | Ruiyue Xu (Huawei) | xuruiyue@huawei.com | Rel-19 | 102 |
| 189 | 136 | Study on closed control loop management | 180d | 2024-01-03 A | 2024-09-06 | 5% | 171d | 387d | start no earlier than 2024-01-03 | S5 | 1440h |  | FS_CCLM | 52 | Deepanshu Gautam (Samsung) | deepanshu.g@samsung.com | Rel-19 | 102 |
| 190 | 137 | Study on management aspects of Network Digital Twin | 180d | 2024-01-03 A | 2024-09-06 | 5% | 171d | 387d | start no earlier than 2024-01-03 | S5 | 1440h |  | FS_NDT | 52 | Yushuang Hu (China Mobile) | huyushuang@chinamobile.com | Rel-19 | 102 |
| 191 | 138 | Study on Cloud Aspects of Management and Orchestration | 180d | 2024-01-03 A | 2024-09-06 | 2% | 176.4d | 387d | start no earlier than 2024-01-03 | S5 | 1440h |  | FS_Cloud_OAM | 52 | Bahar Sadeghi (Microsoft) | bahar.sadeghi@microsoft.com | Rel-19 | 102 |

Notes:
- 122: 6/9/23: 0%->95; 8/12/23: 95%->100
- 123: 17/8/22: WID:SP-220444->SP-220680; 9/9/22: 0%->20; 23/9/22: WID:SP-220680->SP-220954; 10/12/22: 20%->45; 17/3/23: 45%->65; 8/6/23: 65%->95; 8/6/23: FCD:06/06/2023->09/20; 6/9/23: 95%->100
- 124: 14/3/24: 0%->50
- 125: 6/9/23: 0%->95; 8/12/23: 95%->100
- 126: ; 8/12/23: 0%->20; 14/3/24: 20%->40 / Impacted TSs and TRs: 23.255; 23.434
- 127: 3/4/24: 33.759 added; / Impacted TSs and TRs: 33.759
- 128: 13/7/22: 22.841 added;; 9/9/22: 0%->30; 10/12/22: 30%->60; 17/3/23: 60%->75; 8/6/23: 75%->90; 8/6/23: FCD:06/06/2023->09/20; 6/9/23: 90%->95; 8/12/23: 95%->100 / Impacted TSs and TRs: 22.841
- 129: ; 8/12/23: 0%->95 / Impacted TSs and TRs: 22.261
- 130: 14/3/24: 0%->30; 2/4/24: WID:SP-231802->SP-240467; 2/4/24: FCD:09/09/2024->/24
- 131: 3/4/24: 33.754 added; / Impacted TSs and TRs: 33.754
- 132: ; 6/9/23: 0%->100 / Impacted TSs and TRs: 22.261
- 133: 14/3/24: 0%->50
- 134: 3/4/24: 33.749 added; / Impacted TSs and TRs: 33.749
- 135: 14/3/24: 0%->40
- 136: 3/4/24: 33.745 added; / Impacted TSs and TRs: 33.745
- 137: 14/3/24: 0%->45
- 138: 3/4/24: 33.743 added; / Impacted TSs and TRs: 33.743
- 139: 14/3/24: 0%->40; 2/4/24: WID:SP-231799->SP-240493
- 140: 14/3/24: 0%->35; 14/3/24: 23.700-32 added; / Impacted TSs and TRs: 23.700-32
- 141: 3/4/24: 33.700-32 added; / Impacted TSs and TRs: 33.700-32
- 142: ; 4/6/22: 0%->15; 21/6/22: WID:SP-220088->SP-220437. FS_FRMCS_Ph3->FS_FRMCS_Ph5; 9/9/22: 15%->30; 10/12/22: 30%->50; 8/6/23: 50%->80; 8/6/23: FCD:09/09/2023->12/20; 6/9/23: 80%->90; 8/12/23: 90%->100 / Impacted TSs and TRs: 22.989
- 143: ; 6/9/23: 0%->50; 8/12/23: 50%->100 / Impacted TSs and TRs: 22.280; 22.179; 22.289; 22.261
- 144: ; 8/10/19: 22.890 added;; 6/12/19: 0%->5; 5/12/20: 5%->15; 19/3/21: FCD:12/06/2020->09/21; 19/3/21: 15%->30; 13/9/21: 30%->35; 10/12/21: 35%->45; 11/03/22: Rel-18->Rel-19; 9/9/22: 45%->100 / Impacted TSs and TRs: New ; 22.890
- 145: 14/3/24: 0%->45
- 146: 13/7/22: 22.916 added;; 9/9/22: 0%->10; 10/12/22: 10%->40; 17/3/23: FCD:03/03/2023->9/9/23; 17/3/23: 40%->70; 8/6/23: 70%->80; 8/6/23: FCD:09/09/2023->12/20; 6/9/23: 80%->90; 8/12/23: 90%->100 / Impacted TSs and TRs: 22.916
- 147: 8/6/23: 0%->30; 6/9/23: 30%->60; 8/12/23: FCD:12/12/2023->/2024; 8/12/23: 60%->65 / Impacted TSs and TRs: 22.848
- 148: ; 14/3/24: 0%->100 / Impacted TSs and TRs: 22.261
- 149: ; 17/3/23: 0%->100 / Impacted TSs and TRs: 22.104
- 150: ; 9/8/23: 0%->100 / Impacted TSs and TRs: 22.011
- 151: 9/23: company-submitted WID, to be corrected; 6/10/23: 23.700-77 added;; 8/12/23: 0%->15; 14/3/24: 15%->45 / Impacted TSs and TRs: 23.700-77
- 152: ; 9/9/22: 0%->100 / Impacted TSs and TRs: 22.261
- 153: ; 8/6/23: 100%-> / Impacted TSs and TRs: 22.261; 22.280
- 154: ; 9/9/22: 0%->100 / Impacted TSs and TRs: 22.261
- 155: ; 9/9/22: 0%->100 / Impacted TSs and TRs: 22.153
- 156: 9/23: company-submitted WID, to be corrected; 6/10/23: 23.700-75 added;; 8/12/23: 0%->20; 14/3/24: 0%->70 / Impacted TSs and TRs: 23.700-75
- 157: ; 9/9/22: 0%->100 / Impacted TSs and TRs: 22.261
- 158: ; 10/12/22: 0%->100 / Impacted TSs and TRs: 22.261
- 159: ; 6/9/23: 0%->100 / Impacted TSs and TRs: 22.261
- 160: ; 17/3/23: 0%->5; 17/3/23: 26.933 added;; 8/6/23: 5%->30; 7/9/23: 30%->35; 8/12/23: 35%->45; 14/3/24: 45%->70 / Impacted TSs and TRs: 26.933
- 161: ; 30/6/23: 23.700-92 added;; 7/9/23: 0%->10; 8/12/23: 10%->20; 14/3/24: 20%->35 / Impacted TSs and TRs: 23.222 ; 23.700-92
- 162: ; 30/6/23: 23.700-72 added;; 7/9/23: 0%->15; 8/12/23: 15%->25; 14/3/24: 25%->40; 2/4/24: WID:SP-230778->SP-240295; 2/4/24: FCD:05/06/2024->/24 / Impacted TSs and TRs: 23.434 ; 23.700-72
- 163: ; 7/9/23: 0%->5; 8/12/23: 5%->40; 14/3/24: 40%->90 / Impacted TSs and TRs: 23.280; 23.379; 23.281; 23.282
- 164: 7/9/23: 0%->0; 8/12/23: 0%->20; 14/3/24: 20%->35
- 165: Impacted TSs and TRs: 33.501
- 166: ; 7/9/23: 0%->10; 8/12/23: 10%->30; 14/3/24: 30%->40 / Impacted TSs and TRs: 23.280; 23.281; 23.282; 23.379; 23.283; 23.289
- 167: ; 7/9/23: WID:SP-230695->SP-230988; 7/9/23: 0%->5; 8/12/23: 5%->30; 14/3/24: 30%->40 / Impacted TSs and TRs: 23.280; 23.379; 23.281; 23.282; 23.283; 23.289
- 168: 8/12/23: 0%->25; 14/3/24: 25%->35
- 169: ; 8/12/23: 0%->15; 14/3/24: 15%->35 / Impacted TSs and TRs: 23.558
- 170: 8/12/23: 0%->20; 4/1/24: 23.946 added;; 14/3/24: 20%->55 / Impacted TSs and TRs: 23.946
- 171: 14/3/24: 0%->20; 3/4/24: 23.700-22 added; / Impacted TSs and TRs: 23.700-22
- 174: ; 8/12/23: 0%->10; 3/4/24: 33.530 added; / Impacted TSs and TRs: 33.926 ; 33.530
- 175: 8/12/23: 0%->10; 4/1/24: 33.529 added;; 14/3/24: 10%->40 / Impacted TSs and TRs: 33.529
- 176: 8/12/23: 0%->10; 4/1/24: 35.248 added;; 14/3/24: 10%->100; 2/4/24: WID:SP-231159->SP-240476 / Impacted TSs and TRs: 35.248; 35.247; 35.246; 35.245; 35.244; 35.243; 35.242; 35.241; 35.240
- 177: 4/1/24: 35.237 added;; 4/1/24: 35.236 added;; 4/1/24: 35.235 added;; 4/1/24: 35.234 added;; 14/3/24: 0%->5 / Impacted TSs and TRs: 35.237; 35.236; 35.235; 35.234
- 178: 4/1/24: 33.700-41 added;; 14/3/24: 0%->10 / Impacted TSs and TRs: 33.700-41
- 179: 4/1/24: 33.794 added;; 14/3/24: 0%->20 / Impacted TSs and TRs: 33.794
- 180: ; 14/3/24: 0%->10 / Impacted TSs and TRs: 33.180
- 181: 4/1/24: 33.790 added;; 14/3/24: 0%->17; 2/4/24: WID:SP-231785->SP-240233 / Impacted TSs and TRs: 33.790
- 182: 4/1/24: 33.776 added;; 14/3/24: 0%->15 / Impacted TSs and TRs: 33.776
- 183: ; 14/3/24: 0%->20 / Impacted TSs and TRs: 33.127; 33.203; 33.210; 33.222; 33.246; 33.259; 33.303; 33.310; 33.401; 33.402; 33.434; 33.501
- 184: 4/1/24: 33.701 added;; 14/3/24: 0%->20 / Impacted TSs and TRs: 33.701
- 185: 4/1/24: 33.702 added;; 14/3/24: 0%->25 / Impacted TSs and TRs: 33.702
- 188: 14/3/24: 0%->5
- 189: 14/3/24: 0%->5
- 190: 4/1/24: 28.915 added;; 14/3/24: 0%->5 / Impacted TSs and TRs: 28.915
- 191: 14/3/24: 0%->2

| ID | WBS | Task | Duration | Start | Finish | Complete | Remaining | Total slack | Constraint | Resources | Work | Actual work | Acronym | PCG approved | WI rapporteur name | WI rapporteur e-mail | Release | TSG approved | Status Report |
| --- | --- | --- | --- | --- | --- | --- | --- | --- | --- | --- | --- | --- | --- | --- | --- | --- | --- | --- | --- |
| 192 | 139 | Study on Enablers for Security Monitoring | 180d | 2024-01-03 | 2024-09-06 |  |  | 387d | start no earlier than 2024-01-03 | S5 | 1440h |  | FS_SECM | 52 | Clifton Fernandes (Nokia) | clifton.fernandes@nokia.com | Rel-19 | 102 |  |
| 193 | 140 | Study on Service Based Management Architecture enhancement phase 3 | 180d | 2024-01-03 | 2024-09-06 |  |  | 387d | start no earlier than 2024-01-03 | S5 | 1440h |  | FS_SBMA_Ph3 | 52 | Kai Zhang (Huawei) | kai.zhangkai@huawei.com | Rel-19 | 102 |  |
| 194 | 141 | Study on Management of planned configurations | 180d | 2024-01-04 | 2024-09-09 |  |  | 386d | finish no earlier than 2024-09-09 | S5 | 1440h |  | FS_PlanM | 52 | Olaf Pollakowski (Nokia) | olaf.pollakowski@nokia.com | Rel-19 | 102 |  |
| 195 | 142 | Data management phase 2 | 374d | 2024-01-03 | 2025-06-05 |  |  | 193d | start no earlier than 2024-01-03 | S5 | 2992h |  | MADCOL_Ph2 | 52 | Sivaramakrishnan Swaminathan (Nokia) | sivaramakrishnan.swaminathan@nokia.com | Rel-19 | 102 |  |
| 196 | 143 | Study on data management regarding subscriptions and reporting | 180d | 2024-01-03 | 2024-09-06 |  |  | 387d | start no earlier than 2024-01-03 | S5 | 1440h |  | FS_Data_SREP | 52 | Robert Petersen (Ericsson) | robert.petersen@ericsson.com | Rel-19 | 102 |  |
| 197 | 144 | 5G performance measurements and KPIs phase 4 | 374d | 2024-01-03 | 2025-06-05 |  |  | 193d | start no earlier than 2024-01-03 | S5 | 2992h |  | PM_KPI_5G_Ph4 | 52 | Primary Rapporteur: XiuMin Chen (China Telecom) | chenxiumin@chinatelecom.cn | Rel-19 | 102 |  |
| 198 | 145 | 5G Advanced NRM features phase 3 | 374d | 2024-01-03 | 2025-06-05 |  |  | 193d | start no earlier than 2024-01-03 | S5 | 2992h |  | AdNRM_Ph3 | 52 | Sean Sun (Nokia) | sean.sun@nokia-sbell.com | Rel-19 | 102 |  |
| 199 | 146 | Subscriber and Equipment Trace and QoE collection management | 374d | 2024-01-03 | 2025-06-05 |  |  | 193d | start no earlier than 2024-01-03 | S5 | 2992h |  | TraceQoE_OAM | 52 | Zu Qiang (Ericsson) | zu.qiang@ericsson.com | Rel-19 | 102 |  |
| 200 | 147 | Study on Management Aspects of NTN Phase 2 | 180d | 2024-01-03 | 2024-09-06 |  |  | 387d | start no earlier than 2024-01-03 | S5 | 1440h |  | FS_NTN_OAM_Ph2 | 52 | MingRui Sun (China Unicom) | sunmr19@chinaunicom.cn | Rel-19 | 102 |  |
| 201 | 148 | Study on management of IAB nodes | 180d | 2024-01-03 | 2024-09-06 |  |  | 387d | start no earlier than 2024-01-03 | S5 | 1440h |  | FS_NR_mobile_IAB_OAM | 52 | JunFeng Wang (Ericsson) | junfeng.a.wang@ericsson.com | Rel-19 | 102 |  |
| 202 | 149 | Study on management aspects of RedCap feature | 180d | 2024-01-03 | 2024-09-06 |  |  | 387d | start no earlier than 2024-01-03 | S5 | 1440h |  | FS_NR_RedCap_OAM | 52 | Zhen Xing (China Unicom) | xingz12@chinaunicom.cn | Rel-19 | 102 |  |
| 203 | 150 | Study on Enhancement of Management Aspects related to NWDAF Phase 2 | 180d | 2024-01-03 | 2024-09-06 |  |  | 387d | start no earlier than 2024-01-03 | S5 | 1440h |  | FS_NWDAF_OAM_Ph2 | 52 | Primary Rapporteur: Song Zhao (China Telecom) | zhaosong1@chinatelecom.cn | Rel-19 | 102 |  |
| 204 | 151 | Study on Management of Network Sharing Phase3 | 180d | 2024-01-03 | 2024-09-06 |  |  | 387d | start no earlier than 2024-01-03 | S5 | 1440h |  | FS_NetShare_OAM_Ph3 | 52 | ZhaoNing Wang (China Unicom) | wangzn18@chinaunicom.cn | Rel-19 | 102 |  |
| 205 | 152 | Study on Enhanced OAM for management exposure to external consumers | 180d | 2024-01-03 A | 2024-09-06 | 5% | 171d | 387d | start no earlier than 2024-01-03 | S5 | 1440h |  | FS_MExpo | 52 | Primary Rapporteur: Scott Probasco (Nokia) | scott.probasco@nokia.com | Rel-19 | 102 |  |
| 206 | 153 | Rel-19 NR-only: topics other than band | 1d | 2019-03-07 | 2019-03-07 |  |  | 1827d |  |  |  |  |  |  |  |  | Rel-19 |  |  |
| 207 | 154 | Study on channel modelling enhancements for 7-24GHz for NR | 390d | 2023-12-13 | 2025-06-06 |  |  | 192d | finish no earlier than 2025-06-06 | R1 | 3120h |  | FS_NR_7_24GHz_CHmod | 52 | LEE Daewon, Intel Corporation | daewon.lee@intel.com | Rel-19 | 102 | RP-240265 |
| 208 | 155 | Study on additional topological enhancements for NR | 197d | 2023-12-12 | 2024-09-09 |  |  | 386d | start no earlier than 2023-12-12 | R3 | 1576h |  | FS_NR_WAB_5GFemto | 52 | Min, Tianyang, NTT DOCOMO | tianyang.min.ex@nttdocomo.com | Rel-19 | 102 | RP-240320 |
| 209 | 156 | **NR MIMO Phase 5** | 582d | 2023-12-13 A | 2026-03-03 | 7% | 543.61d | 0d |  | R1 | 12968h | 307.16h | NR_MIMO_Ph5 | 52 | Samsung |  | Rel-19 | 102 |  |
| 210 | 156.1 | Core part: NR MIMO Phase 5 | 457d | 2023-12-13 A | 2025-09-09 | 15% | 388.45d | 125d | finish no earlier than 2025-09-09 | R1 | 3656h |  | NR_MIMO_Ph5-Core | 52 | Eko Onggosanusi, Samsung | eko.o@samsung.com | Rel-19 | 102 | RP-240086 |
| 211 | 156.2 | Perf. part: NR MIMO Phase 5 | 582d | 2023-12-13 | 2026-03-03 |  |  | 0d | finish no earlier than 2026-03-03 | R4 | 4656h |  | NR_MIMO_Ph5-Perf | 52 | Eko Onggosanusi, Samsung | eko.o@samsung.com | Rel-19 | 102 | RP-240086 |
| 212 | 157 | **Evolution of NR duplex operation: Sub-band full duplex (SBFD)** | 582d | 2023-12-13 A | 2026-03-03 | 3% | 564.09d | 0d |  | R1 | 12968h | 143.31h | NR_duplex_evo | 52 | Huawei |  | Rel-19 | 102 |  |
| 213 | 157.1 | Core part: Evolution of NR duplex operation: Sub-band full duplex (SBFD) | 457d | 2023-12-13 A | 2025-09-09 | 7% | 425.01d | 125d | finish no earlier than 2025-09-09 | R1 | 3656h |  | NR_duplex_evo-Core | 52 | Xinghua Song, He (Jackson) Wang, Huawei, Samsung | songxinghua@huawei.com, h0809.wang@samsung.com | Rel-19 | 102 | RP-240171 |
| 214 | 157.2 | Perf. part: Evolution of NR duplex operation: Sub-band full duplex (SBFD) | 582d | 2023-12-13 | 2026-03-03 |  |  | 0d | finish no earlier than 2026-03-03 | R4 | 4656h |  | NR_duplex_evo-Perf | 52 | Xinghua Song, He (Jackson) Wang, Huawei, Samsung | songxinghua@huawei.com, h0809.wang@samsung.com | Rel-19 | 102 | RP-240171 |
| 215 | 158 | **NR mobility enhancements Phase 4** | 582d | 2023-12-13 | 2026-03-03 |  |  | 0d |  | R2 | 12968h |  | NR_Mob_Ph4 | 52 | Apple |  | Rel-19 | 102 |  |
| 216 | 158.1 | Core part: NR mobility enhancements Phase 4 | 457d | 2023-12-13 | 2025-09-09 |  |  | 125d | finish no earlier than 2025-09-09 | R2 | 3656h |  | NR_Mob_Ph4-Core | 52 | Naveen Palle, Apple Inc. | naveen.palle@apple.com | Rel-19 | 102 | RP-240298 |
| 217 | 158.2 | Perf. part: NR mobility enhancements Phase 4 | 582d | 2023-12-13 | 2026-03-03 |  |  | 0d | finish no earlier than 2026-03-03 | R4 | 4656h |  | NR_Mob_Ph4-Perf | 52 | Naveen Palle, Apple Inc. | naveen.palle@apple.com | Rel-19 | 102 | RP-240298 |

Notes:
- 192: 4/1/24: 28.870 added; / Impacted TSs and TRs: 28.870
- 194: 4/1/24: 28.872 added; / Impacted TSs and TRs: 28.872
- 195: Impacted TSs and TRs: 28.622; 28.623
- 197: Impacted TSs and TRs: 28.552; 32.425; 28.554; 28.532; 28.550; 28.abc
- 198: Impacted TSs and TRs: 28.540; 28.541; 28.622; 28.623
- 199: Impacted TSs and TRs: 32.421; 32.422; 32.423; 28.404; 28.405; 28.406; 28.622; 28.623
- 205: 14/3/24: 0%->5
- 207: 14/3/24: Stat Rep: ->RP-240265; Rapporteur: Intel->LEE Daewon, Intel Corporation; Rap eMail: ->daewon.lee@intel.com;
- 208: 14/3/24: FCD:28/05/2021->09/09/2024; Stat Rep: ->RP-240320; Rapporteur: NTT DOCOMO->Min, Tianyang, NTT DOCOMO; Rap eMail: ->tianyang.min.ex@nttdocomo.com; ; 2/4/24: WID:RP-234041->RP-240319; 3/4/24: 38.799 added; / Impacted TSs and TRs: 38.799
- 209: 2/4/24: WID:RP-234007->RP-240087
- 210: 14/3/24: Compl:0%->15%; Stat Rep: ->RP-240086; Rapporteur: Samsung->Eko Onggosanusi, Samsung; Rap eMail: ->eko.o@samsung.com;
- 211: 14/3/24: Stat Rep: ->RP-240086; Rapporteur: Samsung->Eko Onggosanusi, Samsung; Rap eMail: ->eko.o@samsung.com;
- 212: 2/4/24: WID:RP-234035->RP-240789
- 213: 14/3/24: Compl:0%->7%; Stat Rep: ->RP-240171; Rapporteur: Huawei->Xinghua Song, He (Jackson) Wang, Huawei, Samsung; Rap eMail: ->songxinghua@huawei.com, h0809.wang@samsung.com;
- 214: 14/3/24: Stat Rep: ->RP-240171; Rapporteur: Huawei->Xinghua Song, He (Jackson) Wang, Huawei, Samsung; Rap eMail: ->songxinghua@huawei.com, h0809.wang@samsung.com;
- 215: 2/4/24: WID:RP-234036->RP-240299
- 216: 14/3/24: Stat Rep: ->RP-240298; Rapporteur: Apple->Naveen Palle, Apple Inc.; Rap eMail: ->naveen.palle@apple.com;
- 217: 14/3/24: Stat Rep: ->RP-240298; Rapporteur: Apple->Naveen Palle, Apple Inc.; Rap eMail: ->naveen.palle@apple.com;

| ID | WBS | Task | Type | Duration | Start | Finish | Complete | Remaining | Total slack | Constraint | Resources | Work | Actual work | Acronym | PCG approved | WI rapporteur name | Release | TSG approved | WI rapporteur e-mail | Status Report | Impacted TSs and TRs |
| --- | --- | --- | --- | --- | --- | --- | --- | --- | --- | --- | --- | --- | --- | --- | --- | --- | --- | --- | --- | --- | --- |
| 218 | 159 | **Data collection for SON (Self-Organising Networks)/MDT (Minimization of Drive Tests) in NR standalone and MR-DC (Multi-Radio Dual Connectivity) Phase 4** |  | 457d | 2023-12-13 | 2025-09-09 |  |  | 125d |  | R3 | 7312h |  | NR_ENDC_SON_MDT_Ph4 | 52 | China Unicom | Rel-19 | 102 |  |  |  |
| 219 | 159.1 | Core part: Data collection for SON (Self-Organising Networks)/MDT (Minimization of Drive Tests) in NR standalone and MR-DC (Multi-Radio Dual Connectivity) Phase 4 |  | 457d | 2023-12-13 | 2025-09-09 |  |  | 125d | finish no earlier than 2025-09-09 | R3 | 3656h |  | NR_ENDC_SON_MDT_Ph4-Core | 52 | Xufei Dong, China Unicom | Rel-19 | 102 | dongxf37@chinaunicom.cn | RP-240118 |  |
| 220 | 160 | Study on 6 GHz for LTE and NR |  | 1624d? | 2017-12-15 A | 2024-03-03 A | 100% |  |  | finish no earlier than 2024-03-03 | RP | 12992h | 12992h | FS_6GHz_LTE_NR | 40 | Dominique Everaere, Ericsson | Rel-19 | 78 | dominique.everaere@ericsson.com | RP-231702 | 37.890; 37.107 |
| 221 | 161 | Study on NR FR2 OTA (Over the Air) testing Phase 3 |  | 399d | 2024-03-03 | 2025-09-09 |  |  | 125d | finish no earlier than 2025-09-09 | R4 | 3192h |  | FS_NR_FR2_OTA_Ph3 |  | Qualcomm | Rel-19 |  |  | SI |  |
| 222 | 162 | Study on IMT parameters for NR for 4400 to 4800 MHz, 7125 to 8400 MHz and 14800 to 15350 MHz |  | 524d | 2019-03-07 | 2021-03-09 |  |  | 1304d |  | R4 | 4192h |  | FS_NR_IMT_4400_7125_14800MHz |  | Ericsson | Rel-19 |  |  | SI |  |
| 223 | 163 | **NR base station (BS) RF requirement evolution for FR1/FR2 and testing** |  | 524d | 2024-03-03 | 2026-03-03 |  |  | 0d |  | R4 | 11576h |  | NR_BS_RF_req_evo |  | ZTE | Rel-19 |  |  |  |  |
| 224 | 163.1 | Core part: NR base station (BS) RF requirement evolution for FR1/FR2 and testing |  | 399d | 2024-03-03 | 2025-09-09 |  |  | 125d | finish no earlier than 2025-09-09 | R4 | 3192h |  | NR_BS_RF_req_evo-Core |  | ZTE | Rel-19 |  |  |  |  |
| 225 | 163.2 | Perf. part: NR base station (BS) RF requirement evolution for FR1/FR2 and testing |  | 524d | 2024-03-03 | 2026-03-03 |  |  | 0d | finish no earlier than 2026-03-03 | R4 | 4192h |  | NR_BS_RF_req_evo-Perf |  | ZTE | Rel-19 |  |  |  |  |
| 226 | 164 | **NR Radio Resource Management (RRM) Phase 5** |  | 524d | 2024-03-03 | 2026-03-03 |  |  | 0d |  | R4 | 11576h |  | NR_RRM_Ph5 |  | Apple | Rel-19 |  |  |  |  |
| 227 | 164.1 | Core part: NR Radio Resource Management (RRM) Phase 5 |  | 399d | 2024-03-03 | 2025-09-09 |  |  | 125d | finish no earlier than 2025-09-09 | R4 | 3192h |  | NR_RRM_Ph5-Core |  | Apple | Rel-19 |  |  |  |  |
| 228 | 164.2 | Perf. part: NR Radio Resource Management (RRM) Phase 5 |  | 524d | 2024-03-03 | 2026-03-03 |  |  | 0d | finish no earlier than 2026-03-03 | R4 | 4192h |  | NR_RRM_Ph5-Perf |  | Apple | Rel-19 |  |  |  |  |
| 229 | 165 | **NR demodulation performance Phase 5** |  | 524d | 2024-03-03 | 2026-03-03 |  |  | 0d |  | R4 | 8384h |  | NR_demod_Ph5 |  | China Telecom | Rel-19 |  |  |  |  |
| 230 | 165.1 | Perf. part: NR demodulation performance Phase 5 |  | 524d | 2024-03-03 | 2026-03-03 |  |  | 0d | finish no earlier than 2026-03-03 | R4 | 4192h |  | NR_demod_Ph5-Perf |  | China Telecom | Rel-19 |  |  |  |  |
| 231 | 166 | **NR channel BW less than 5MHz for FR1 Phase 2** |  | 332d | 2024-03-03 | 2025-06-06 |  |  | 192d |  | R4 | 6960h |  | NR_FR1_lessthan_5MHz_BW_Ph2 |  | Intel | Rel-19 |  |  |  |  |
| 232 | 166.1 | Core part: NR channel BW less than 5MHz for FR1 Phase 2 |  | 206d | 2024-03-03 | 2024-12-12 |  |  | 318d | finish no earlier than 2024-12-12 | R4 | 1648h |  | NR_FR1_lessthan_5MHz_BW_Ph2-Core |  | Intel | Rel-19 |  |  |  |  |
| 233 | 166.2 | Perf. part: NR channel BW less than 5MHz for FR1 Phase 2 |  | 332d | 2024-03-03 | 2025-06-06 |  |  | 192d | finish no earlier than 2025-06-06 | R4 | 2656h |  | NR_FR1_lessthan_5MHz_BW_Ph2-Perf |  | Intel | Rel-19 |  |  |  |  |
| 234 | 167 | **Enhancements for Air-to-ground network for NR** |  | 524d | 2024-03-03 | 2026-03-03 |  |  | 0d |  | R4 | 11576h |  | NR_ATG_enh |  | CMCC | Rel-19 |  |  |  |  |
| 235 | 167.1 | Core part: Enhancements for Air-to-ground network for NR |  | 399d | 2024-03-03 | 2025-09-09 |  |  | 125d | finish no earlier than 2025-09-09 | R4 | 3192h |  | NR_ATG_enh-Core |  | CMCC | Rel-19 |  |  |  |  |
| 236 | 167.2 | Perf. part: Enhancements for Air-to-ground network for NR |  | 524d | 2024-03-03 | 2026-03-03 |  |  | 0d | finish no earlier than 2026-03-03 | R4 | 4192h |  | NR_ATG_enh-Perf |  | CMCC | Rel-19 |  |  |  |  |
| 237 | 168 | **NR Sidelink: Intra-band Carrier Aggregation in ITS band** |  | 399d | 2024-03-03 | 2025-09-09 |  |  | 125d |  | R4 | 6384h |  | NR_SL_intraB_CA_ITS |  | OPPO | Rel-19 |  |  |  |  |
| 238 | 168.1 | Core part: NR Sidelink: Intra-band Carrier Aggregation in ITS band |  | 399d | 2024-03-03 | 2025-09-09 |  |  | 125d | finish no earlier than 2025-09-09 | R4 | 3192h |  | NR_SL_intraB_CA_ITS-Core |  | OPPO | Rel-19 |  |  |  |  |
| 239 | 169 | Rel-19 other |  | 1d | 2019-03-07 | 2019-03-07 |  |  | 1827d |  |  |  |  |  |  |  | Rel-19 |  |  |  |  |
| 240 | 170 | Lawful Interception Rel-19 |  | 385d | 2023-03-24 | 2024-09-09 |  |  | 386d | finish no earlier than 2024-09-09 | S3LI | 3080h |  | LI19 | 49 | Koen Jaspers, PIDS | Rel-19 | 97 | kbj@xs4all.nl |  | 33.107; 33.108; 33.126; 33.127; 33.128 |
| 241 | 171 | (Small) Technical Enhancements and Improvements for Rel-19 |  | 67d | 2022-09-09 A | 2022-12-12 |  | 67d | 844d | finish no earlier than 2022-12-12 |  |  |  | TEI19 | 47 |  | Rel-19 | 92 |  |  |  |
| 242 | 172 | --- RELEASE 18 --- | milestone | 0d? | 2016-03-15 A | 2016-03-15 A | 100% |  |  | start no earlier than 2016-03-15 |  |  |  |  |  |  | Rel-18 |  |  |  |  |
| 243 | 173 | Rel-18 Satellite (5GSAT), NTN | milestone | 0d? | 2016-03-15 A | 2016-03-15 A | 100% |  |  | start no earlier than 2016-03-15 |  |  |  |  |  |  | Rel-18 |  |  |  |  |

Notes:
- 219: 14/3/24: Stat Rep: ->RP-240118; Rapporteur: China Unicom->Xufei Dong, China Unicom; Rap eMail: ->dongxf37@chinaunicom.cn;
- 220: 27/3/18: Compl:0%->25%27/3/18: WID: RP-172804->RP-180168¦27/3/18: 37.890 added;¦27/3/18: 37.107 added;¦27/6/18: Compl:25%->30%¦27/6/18: CD:Fri 15/¦26/3/19: WID:RP-181019->RP-190681; 26/6/19: WID:RP-190681->RP-190957¦01/24: Rel-18->Rel-19; 2/1/24: WID:R...; 2/4/24: 98%->100
- 240: ; 16/3/23: WID:SP-220752->SP-230242; 16/3/23: FCD:03/03/2024->9/9/2024. Rapporteur changed from Alex Leadbeater
- 242: -
- 243: -

| ID | WBS | Task | Duration | Start | Finish | Complete | Remaining | Total slack | Constraint | Resources | Work | Actual work | Acronym | PCG approved | WI rapporteur name | WI rapporteur e-mail | Release | TSG approved | Status Report |
| --- | --- | --- | --- | --- | --- | --- | --- | --- | --- | --- | --- | --- | --- | --- | --- | --- | --- | --- | --- |
| 244 | 174 | **5G system with satellite backhaul** | 655d | 2021-06-11 A | 2023-12-12 A | 100% |  |  |  |  | 8248h | 8248h | 5GSATB | 47 | Xu Hui, CATT | xuhui@catt.cn | Rel-18 | 92 |  |
| 245 | 174.1 | Stage 1 of 5GSATB | 6d | 2021-06-11 A | 2021-06-18 A | 100% |  |  | finish no earlier than 2021-06-20 | S1 | 48h | 48h | 5GSATB | 47 | Xu Hui, CATT | xuhui@catt.cn | Rel-18 | 92 |  |
| 246 | 174.2 | Study on Support of Satellite Backhauling in 5GS | 315d | 2021-12-20 A | 2023-03-03 A | 100% |  |  | finish no earlier than 2023-03-12 | S2 | 2520h | 2520h | FS_5GSATB | 48 | Hucheng Wang, CATT | wanghucheng@catt.cn | Rel-18 | 94 |  |
| 247 | 174.3 | Stage 2 of 5GSATB | 192d | 2022-09-12 A | 2023-06-06 A | 100% |  |  | finish no earlier than 2023-06-06 | S2 | 1536h | 1536h | 5GSATB | 49 | Hucheng Wang, CATT | wanghucheng@catt.cn | Rel-18 | 97 |  |
| 248 | 174.4 | CT3 aspects of 5GSATB | 259d | 2022-12-16 A | 2023-12-12 A | 100% |  |  | finish no earlier than 2023-12-12 | C3 | 2072h | 2072h | 5GSATB | 49 | Hou, Yunjing, CATT | houyunjing@catt.cn | Rel-18 | 97 |  |
| 249 | 174.5 | CT4 aspects of 5GSATB | 259d | 2022-12-16 A | 2023-12-12 A | 100% |  |  | finish no earlier than 2023-12-12 | C4 | 2072h | 2072h | 5GSATB | 49 | Hou, Yunjing, CATT | houyunjing@catt.cn | Rel-18 | 97 |  |
| 250 | 175 | Charging aspects of Satellite Backhaul in 5GS | 63d | 2023-12-07 A | 2024-03-03 A | 100% |  |  | finish no earlier than 2024-03-03 | S5 | 504h | 504h | 5GSATB_CH | 52 | Yingying, Liu, CATT | liuyingying@cictmobile.com | Rel-18 | 102 |  |
| 251 | 176 | Management aspects of 5G system supporting satellite backhaul | 63d | 2023-12-07 A | 2024-03-03 A | 100% |  |  | finish no earlier than 2024-03-03 | S5 | 504h | 504h | 5GSATB_OAM | 52 | Wen Qi, China Telecom | qiw@chinatelecom.cn | Rel-18 | 102 |  |
| 252 | 177 | 5G system with satellite access to Support Control and/or Video Surveillance | 64d | 2021-06-11 A | 2021-09-08 A | 100% |  |  | finish no earlier than 2021-09-08 | S1 | 512h | 512h | SCVS | 47 | Dong Chen, Xiaomi | chendong7@xiaomi.com | Rel-18 | 92 |  |
| 253 | 178 | Study on 5GC enhancement for satellite access Phase 2 | 256d | 2021-12-20 A | 2022-12-12 A | 100% |  |  | finish no earlier than 2022-12-12 | S2 | 2048h | 2048h | FS_5GSAT_Ph2 | 48 | Fine, Jean-Yves, Thales | jean-yves.fine@thalesgroup.com. | Rel-18 | 94 |  |
| 254 | 179 | **Satellite access Phase 2** | 323d | 2022-12-09 A | 2024-03-03 A | 100% |  |  |  |  | 6168h | 6168h | 5GSAT_Ph2 | 50 | Rapporteur: Jean-Yves Fine, Thales | jean-yves.fine@thalesgroup.com | Rel-18 | 98 |  |
| 255 | 179.1 | (Stage 2 of 5GSAT_Ph2) 5GC/EPC enhancement for satellite access Phase 2 | 128d | 2022-12-09 A | 2023-06-06 A | 100% |  |  | finish no earlier than 2023-06-06 | S2 | 1024h | 1024h | 5GSAT_Ph2 | 50 | Rapporteur: Jean-Yves Fine, Thales | jean-yves.fine@thalesgroup.com | Rel-18 | 98 |  |
| 256 | 179.2 | CT1 aspects of 5GSAT_Ph2 | 257d | 2023-03-13 A | 2024-03-03 A | 100% |  |  | finish no earlier than 2024-03-03 | C1 | 2056h | 2056h | 5GSAT_Ph2 | 50 | Amer Catovic, Qualcomm Incorporated | amerc@qti.qualcomm.com | Rel-18 | 99 |  |
| 257 | 179.3 | deleted - CT6 aspects of 5GSAT_Ph2 | 257d | 2023-03-13 A | 2024-03-03 A | 100% |  |  | finish no earlier than 2024-03-03 | C6 | 2056h | 2056h | 5GSAT_Ph2 | 50 | Amer Catovic, Qualcomm Incorporated | amerc@qti.qualcomm.com | Rel-18 | 99 |  |
| 258 | 179.4 | Charging aspects of 5GSAT | 129d | 2023-09-07 A | 2024-03-03 A | 100% |  |  | finish no earlier than 2024-03-03 | S5 | 1032h | 1032h | 5GSAT_Ph2_CH | 51 | Yingying, Liu, CATT | liuyingying@cictmobile.com | Rel-18 | 101 |  |
| 259 | 180 | **NR NTN (Non-Terrestrial Networks) enhancements** | 652d | 2021-12-13 A | 2024-06-06 | 67% | 214.83d | 453d |  |  | 10416h |  | NR_NTN_enh | 48 | Thales |  | Rel-18 | 94 |  |
| 260 | 180.1 | Core part: NR NTN (Non-Terrestrial Networks) enhancements | 652d | 2021-12-13 A | 2024-06-06 | 99% | 6.52d | 453d | finish no earlier than 2024-06-06 | R2 | 5216h |  | NR_NTN_enh-Core | 48 | Nicolas Chuberre, Thales | Nicolas.chuberre@thalesaleniaspace.com | Rel-18 | 94 | RP-240127 |
| 261 | 180.2 | Perf. part: NR NTN (Non-Terrestrial Networks) enhancements | 650d | 2021-12-15 A | 2024-06-06 | 35% | 422.5d | 453d | finish no earlier than 2024-06-06 | R2 | 5200h |  | NR_NTN_enh-Perf | 48 | Nicolas Chuberre, Thales | Nicolas.chuberre@thalesaleniaspace.com | Rel-18 | 94 | RP-240127 |
| 262 | 181 | **IoT (Internet of Things) NTN (non-terrestrial network) enhancements** | 1048d | 2021-12-13 A | 2025-12-12 | 48% | 544.67d | 57d |  |  | 12656h | 4184h | IoT_NTN_enh | 48 | MediaTek |  | Rel-18 | 94 |  |
| 263 | 181.1 | Core part: IoT (Internet of Things) NTN (non-terrestrial network) enhancements | 523d | 2021-12-13 A | 2023-12-12 A | 100% |  |  | finish no earlier than 2023-12-12 | R2 | 4184h | 4184h | IoT_NTN_enh-Core | 48 | Abhishek Roy, MediaTek | abhishek.roy@mediatek.com | Rel-18 | 94 | RP-233260 |
| 264 | 181.2 | Perf. Part: IoT (Internet of Things) NTN (non-terrestrial network) enhancements | 592d | 2022-03-07 A | 2024-06-06 | 40% | 355.2d | 453d | finish no earlier than 2024-06-06 | R4 | 4736h |  | IoT_NTN_enh-Perf | 48 | Abhishek Roy, MediaTek | abhishek.roy@mediatek.com | Rel-18 | 95 | RP-240446 |
| 265 | 181.3 | UE Conformance - IoT (Internet of Things) NTN (non-terrestrial network) enhancements plus CT1 aspects | 467d | 2024-03-03 | 2025-12-12 |  |  | 57d | finish no earlier than 2025-12-12 | R5 | 3736h |  | IoT_NTN_enh-UEConTest |  | CMCC |  | Rel-18 |  |  |
| 266 | 182 | **Introduction of the satellite L-/S-band for NR** | 262d | 2022-12-13 A | 2023-12-12 A | 100% |  |  |  |  | 4192h | 4192h | NR_NTN_LSband | 50 | Apple |  | Rel-18 | 98 |  |
| 267 | 182.1 | Core part: Introduction of the satellite L-/S-band for NR | 262d | 2022-12-13 A | 2023-12-12 A | 100% |  |  | finish no earlier than 2023-12-12 | R4 | 2096h | 2096h | NR_NTN_LSband-Core | 50 | Alexander Sayenko, Apple Inc. | asayenko@apple.com | Rel-18 | 98 | RP-233306 |
| 268 | 182.2 | Perf. part: Introduction of the satellite L-/S-band for NR | 262d | 2022-12-13 A | 2023-12-12 A | 100% |  |  | finish no earlier than 2023-12-12 | R4 | 2096h | 2096h | NR_NTN_LSband-Perf | 50 | Alexander Sayenko, Apple Inc. | asayenko@apple.com | Rel-18 | 98 | RP-233306 |
| 269 | 183 | Study on Security Aspects of Satellite Access | 125d | 2022-09-12 A | 2023-03-03 A | 100% |  |  | finish no earlier than 2023-03-03 | S3 | 1000h | 1000h | FS_5GSAT_Sec | 49 | Wei Lu, Xiaomi | luwei10@xiaomi.com | Rel-18 | 97 |  |
| 270 | 184 | Study on Management Aspects of IoT NTN Enhancements | 264d | 2022-06-02 A | 2023-06-06 A | 100% |  |  | finish no earlier than 2023-06-06 | S5 | 2112h | 2112h | FS_IoT_NTN | 49 | Sun Mingrui, China Unicom | sunmr19@chinaunicom.cn | Rel-18 | 96 |  |
| 271 | 185 | Study on requirements and use cases for network verified UE location for Non-Terrestrial-Networks (NTN) in NR | 11d | 2022-06-01 A | 2022-06-15 A | 100% |  |  | start no earlier than 2022-06-01 | RP | 88h | 88h | FS_NR_NTN_netw_verif_UE_loc | 49 | Thales |  | Rel-18 | 96 |  |
| 272 | 186 | Study on charging aspects of Satellite in 5GS | 401d | 2022-06-01 A | 2023-12-12 A | 100% |  |  | start no earlier than 2022-06-01 | S5 | 3208h | 3208h | FS_5GSAT_CH | 50 | Yingying, Liu, CATT | liuyingying@cictmobile.com | Rel-18 | 98 |  |

Notes:
- 244: ; 11/6/21: 0%->100; / Impacted TSs and TRs: 22.261
- 245: ; 11/6/21: 0%->100; / Impacted TSs and TRs: 22.261
- 246: 21/1/22: 23.700-27 added;; 12/3/22: 0%->15; 4/6/22: 15%->60; 12/9/22: 60%->80; 10/12/22: 80%->100 / Impacted TSs and TRs: 23.700-27
- 247: ; 10/12/22: 0%->30; 15/3/23: FCD:03/03/2023->06/23; 15/3/23: 30%->65; 15/3/23: WID:SP-220808->SP-230111; 8/6/23: 65%->100 / Impacted TSs and TRs: 23.501; 23.502; 23.503
- 248: 6/6/23: Compl:30%->60% / Impacted TSs and TRs: 29.512; 29.514; 29.522; 29.525; 29.513; 29.502; 29.244; 29.564
- 249: Impacted TSs and TRs: 29.512; 29.514; 29.522; 29.525; 29.513; 29.502; 29.244; 29.564
- 250: SP-231707 shows UID 1020023 but this duplicates with SP-231706, so changed here to 1020024.; 15/3/24: 0%->100; 2/4/24: WID:SP-231707->SP-240266 / Impacted TSs and TRs: 32.240; 32.255; 32.256; 32.254; 32.257; 32.291; 32.298
- 251: ; 14/3/24: 0%->100 / Impacted TSs and TRs: 28.541; 28.552
- 252: ; 10/12/21: 0%->100 / Impacted TSs and TRs: 22.261
- 253: 21/1/22: 23.700-28 added;; 12/3/22: 0%->12; 4/6/22: 12%->50; 12/9/22: 50%->75; 12/9/22: FCD:12/09/2022->12/22; 10/12/22: 75%->100 / Impacted TSs and TRs: 23.700-28
- 254: Impacted TSs and TRs: 23.501; 23.502; 23.503; 23.401
- 255: ; 15/3/23: 0%->70; 15/3/23: WID:SP-221344->SP-230109; 8/6/23: 70%->100 / Impacted TSs and TRs: 23.501; 23.502; 23.503; 23.401
- 256: 6/6/23: Compl:0%->10% / Impacted TSs and TRs: 24.501.24.301.23.122.27.007.29.122.29.522.31.102
- 257: ; 15/3/24: 0%->100 / Impacted TSs and TRs: 24.501.24.301.23.122.27.007.29.122.29.522.31.102
- 258: ; 8/12/23: 0%->35; 14/3/24: 35%->100 / Impacted TSs and TRs: 32.255; 32.256; 32.291; 32.298
- 259: compare REL-17 WI NR_NTN_solutions; 5/4/22: WID:RP-213690->RP-220953; 12/7/22: WID:RP-220953->RP-221819; 23/9/22: WID:RP-221819->RP-222654; 9/1/23: WID:RP-222654->RP-223534; 29/3/23: WID:RP-223534->RP-230809; 6/10/23: WID:RP-230809->RP-232669; 2/1/24: ...; 2/4/24: WID:RP-234011->RP-240779
- 260: compare REL-17 WI NR_NTN_solutions; 22/3/22: Stat Rep: ->RP-220383; 20/6/22: FCD:12/12/2023->23/12/2022; Compl:0%->5%; Stat Rep: RP-220383->RP-221170 / 1746; Rapporteur: Thales->Nicolas Chuberre, Thales; Rap eMail: ->Nicolas.chuberre@thalesaleniaspace....; 14/3/24: FCD:01/03/2024->06/06/2024; Compl:95%->99%; WID: RP-234011->RP-232669; Stat Rep: RP-232858->RP-240127;
- 261: ; ; 20/6/22: WG: R4->R2; FCD:12/06/2024->24/06/2022; Stat Rep: RP-220383->RP-221170 / 1746; Rapporteur: Thales->Nicolas Chuberre, Thales; Rap eMail: ->Nicolas.chuberre@thalesaleniaspace.com13/7/22: FCD:24/06/2022->06/20 ...; 9/12/22: FCD:24/06/2023->0...; 14/3/24: FCD:05/06/2024->06/06/2024; Compl:10%->35%; WID: RP-234011->RP-232669; Stat Rep: RP-232858->RP-240127;
- 262: no Perf. part; 5/4/22: WID:RP-213596->RP-220979; 12/7/22: WID:RP-220979->RP-221806; 9/1/23: WID:RP-221806->RP-223519; 2/1/24: WID:RP-223519->RP-234073
- 263: no Perf. Part. Slight misalignment in UID numberring scheme (940104 instead of 941104) but it was decided to leave it as such to avoid further potential problems by changing a UID; 20/6/22: FCD:12/12/2023->23/12/2022; Compl:0%->3%; Stat Rep: ->RP-22155...; 8/12/23: Compl:82%->100%; Stat Rep: RP-232310->RP-233260;
- 264: 20/6/22: WG: R4->R2; FCD:07/06/2024->24/06/2022; Stat Rep: ->RP-221553 / 1759; Rapporteur: MediaTek->Abhishek Roy, MediaTek; Rap eMail: ->abhishek.roy@mediatek.com ...; 17/3/23: FCD:23/12/2022->06/06/2024; Stat Rep: ->RP-230633; Rapporteur: MediaTek...; 14/3/24: FCD:05/06/2024->06/06/2024; Compl:10%->40%; Stat Rep: RP-233260->RP-240446;
- 266: 29/3/23: WID:RP-223485->RP-230706; 8/6/23: 38.741 added;; 2/1/24: WID:RP-230706->RP-234043 / Impacted TSs and TRs: 38.741
- 267: 17/3/23: FCD:12/12/2023->08/09/2023; Compl:0%->10%; Stat Rep: ->RP-230154; Rapporteur: Apple->Alexander Sayenko, Apple Inc.; Rap eMail: ->asayenko@apple.com; 31/3/23: FCD:08/09/2023->12/12/2023; Stat Rep: RP-230154->RP-230707; ...; 6/9/23: Compl:50%->...; 8/12/23: Compl:80%->100%; Stat Rep: RP-231967->RP-233306;
- 268: 17/3/23: Compl:0%->50%; Stat Rep: ->RP-230154; Rapporteur: Apple->Alexander Sayenko, Apple Inc.; Rap eMail: ->asayenko@apple.com; 31/3/23: Stat Rep: RP-230154->RP-230707; ...; 6/9/23: Compl:90%->95%; WID: RP-230706->RP-231179; Stat Rep: RP-230707->RP-...; 8/12/23: Compl:95%->100%; Stat Rep: RP-231967->RP-233306;
- 269: 23/9/22: 33.700-28 added;; 11/12/22: 0%->15; 17/3/23: 15%->25; 8/6/23: 25%->100; 7/9/23: 100%-> / Impacted TSs and TRs: 33.700-28
- 270: 12/9/22: 0%->30; 11/12/22: 30%->75; 11/12/22: FCD:12/12/2022->/23; 17/3/23: 75%->95; 17/3/23: FCD:03/03/2023->/23; 8/6/23: 95%->100
- 272: 17/3/23: 0%->5; 17/3/23: 22.844 added;; 8/6/23: 5%->30; 7/9/23: 0%->80; 8/12/23: 80%->100; 8/12/23: 99%->100 / Impacted TSs and TRs: 22.844

| ID | WBS | Task | Type | Duration | Start | Finish | Complete | Remaining | Total slack | Constraint | Resources | Work | Actual work | Acronym | PCG approved | WI rapporteur name | Release | TSG approved | WI rapporteur e-mail | Status Report |
| --- | --- | --- | --- | --- | --- | --- | --- | --- | --- | --- | --- | --- | --- | --- | --- | --- | --- | --- | --- | --- |
| 273 | 187 | **30 MHz Channel Bandwidth for NR NTN (non-terrestrial networks) in FR1 (frequency range 1)** |  | 68d | 2023-06-07 A | 2023-09-08 A | 100% |  |  |  | R4 | 1088h | 1088h | NR_NTN_CBW_30MHz | 51 | Thales | Rel-18 | 100 |  |  |
| 274 | 187.1 | Core part: 30 MHz Channel Bandwidth for NR NTN (non-terrestrial networks) in FR1 (frequency range 1) |  | 68d | 2023-06-07 A | 2023-09-08 A | 100% |  |  | finish no earlier than 2023-09-08 | R4 | 544h | 544h | NR_NTN_CBW_30MHz-Core | 51 | Dorin Panaitopol, THALES | Rel-18 | 100 | dorin.panaitopol@thalesgroup.com | RP-232646 |
| 275 | 188 | **Introduction of the Extended L-band (UL 1668-1675MHz, DL 1518-1525MHz) for IoT NTN** |  | 333d | 2023-03-03 A | 2024-06-06 | 44% | 186.06d | 453d |  | R4 | 7432h | 4004.89h | IoT_NTN_extLband | 50 | Inmarsat | Rel-18 | 99 |  |  |
| 276 | 188.1 | Core part: Introduction of the Extended L-band (UL 1668-1675MHz, DL 1518-1525MHz) for IoT NTN |  | 263d | 2023-03-03 A | 2024-03-03 A | 100% |  |  | finish no earlier than 2024-03-03 | R4 | 2104h | 2104h | IoT_NTN_extLband-Core | 50 | Luca Lodigiani, Inmarsat | Rel-18 | 99 | Luca.lodigiani@inmarsat.com | RP-232609 |
| 277 | 188.2 | Perf. part: Introduction of the Extended L-band (UL 1668-1675MHz, DL 1518-1525MHz) for IoT NTN |  | 333d | 2023-03-03 | 2024-06-06 |  |  | 453d | finish no earlier than 2024-06-06 | R4 | 2664h |  | IoT_NTN_extLband-Perf | 50 | Luca Lodigiani, Inmarsat | Rel-18 | 99 | Luca.lodigiani@inmarsat.com | RP-232609 |
| 278 | 189 | **Introduction of FDD LTE band (L+S band) for IoT NTN operation** |  | 333d | 2023-03-03 A | 2024-06-06 | 69% | 103.13d | 453d |  | R4 | 6952h | 1935.21h | IoT_NTN_FDD_LS_band | 50 | MediaTek | Rel-18 | 99 |  |  |
| 279 | 189.1 | Core part: Introduction of FDD LTE band (L+S band) for IoT NTN operation |  | 204d | 2023-03-03 A | 2023-12-12 A | 100% |  |  | finish no earlier than 2023-12-12 | R4 | 1632h | 1632h | IoT_NTN_FDD_LS_band-Core | 50 | Huanren FU, MediaTek Inc. | Rel-18 | 99 | huanren.fu@mediatek.com | RP-240450 |
| 280 | 189.2 | Perf. part: Introduction of FDD LTE band (L+S band) for IoT NTN operation |  | 332d | 2023-03-06 A | 2024-06-06 | 50% | 166d | 453d | finish no earlier than 2024-06-06 | R4 | 2656h |  | IoT_NTN_FDD_LS_band-Perf | 50 | Huanren FU, MediaTek Inc. | Rel-18 | 99 | huanren.fu@mediatek.com | RP-240450 |
| 281 | 190 | **NB-IoT/eMTC Core and Perf requirements for NTN** |  | 515d | 2022-03-15 A | 2024-03-01 A | 100% |  |  |  |  | 6632h | 6632h | LTE_NBIOT_eMTC_NTN_req | 48 | MediaTek | Rel-18 | 95 |  |  |
| 282 | 190.1 | Core part: NB-IoT (Narrowband IoT)/eMTC (enhanced Machine Type Communication) core & performance requirements for Non-Terrestrial Networks (NTN) |  | 188d | 2022-03-15 A | 2022-12-01 A | 100% |  |  | finish no earlier than 2022-12-01 | R4 | 1504h | 1504h | LTE_NBIoT_eMTC_NTN_req-Core | 48 | Tim Frost, MediaTek Inc. | Rel-18 | 95 | Tim.frost@mediatek.com | RP-223231 |
| 283 | 190.2 | Perf. part: NB-IoT (Narrowband IoT)/eMTC (enhanced Machine Type Communication) core & performance requirements for Non-Terrestrial Networks (NTN) |  | 321d | 2022-03-15 A | 2023-06-06 A | 100% |  |  | finish no earlier than 2023-06-06 | R4 | 2568h | 2568h | LTE_NBIoT_eMTC_NTN_req-Perf | 48 | Hsuanli Lin, MediaTek Inc. | Rel-18 | 95 | hsuanli.lin@mediatek.com | RP-230634 |
| 284 | 190.3 | UE Conformance - NB-IoT (Narrowband IoT)/eMTC (enhanced Machine Type Communication) core & performance requirements for Non-Terrestrial Networks (NTN) |  | 320d | 2022-12-13 A | 2024-03-01 A | 100% |  |  | finish no earlier than 2024-03-01 | R5 | 2560h | 2560h | LTE_NBIOT_eMTC_NTN_req-UEConTest | 50 | Dan SONG, Danbo Fu (MediaTek), CMCC, MediaTek Inc. | Rel-18 | 98 | songdan@chinamobile.com, Danbo.Fu@mediatek.com | RP-240146 |
| 285 | 191 | Rel-18 Internet of Things (IoT), MTC, Energy, complexity saving | milestone | 0d? | 2016-03-15 A | 2016-03-15 A | 100% |  |  | start no earlier than 2016-03-15 |  |  |  |  |  |  | Rel-18 |  |  |  |
| 286 | 192 | **Personal IoT and Residential networks** |  | 965d | 2020-06-25 A | 2024-03-03 A | 100% |  |  |  |  | 14272h | 14272h | PIRates | 47 | Xiaowan Ke, vivo Mobile Communications Ltd | Rel-18 | 93 | xiaowan.ke@vivo.com |  |
| 287 | 192.1 | Study on Personal IoT Networks |  | 252d | 2020-06-25 A | 2021-06-11 A | 100% |  |  | finish no earlier than 2021-06-12 | S1 | 2016h | 2016h | FS_PIN | 45 | Adrian Buckley, vivo Mobile Communications | Rel-18 | 88 | adrian.buckley@vivo.com |  |
| 288 | 192.2 | Study on Enhancements for Residential 5G |  | 252d | 2020-06-25 A | 2021-06-11 A | 100% |  |  | finish no earlier than 2021-06-12 | S1 | 2016h | 2016h | FS_Resident | 45 | Toon Norp, KPN | Rel-18 | 88 | toon.norp@tno.nl |  |
| 289 | 192.3 | Stage 1 of PIRates |  | 66d | 2021-09-10 A | 2021-12-10 A | 100% |  |  | finish no earlier than 2021-12-12 | S1 | 528h | 528h | PIRates | 47 | Xiaowan Ke, vivo Mobile Communications Ltd | Rel-18 | 93 | xiaowan.ke@vivo.com |  |
| 290 | 192.4 | Study on Personal IoT Networks |  | 315d | 2021-12-20 A | 2023-03-03 A | 100% |  |  | finish no earlier than 2023-03-03 | S2 | 2520h | 2520h | FS_PIN | 48 | Zhenhua Xie, vivo Mobile Communications Ltd | Rel-18 | 94 | zhenhua.xie@vivo.com |  |
| 291 | 192.5 | (Stage 2 of) Personal IoT Networks |  | 128d | 2022-12-09 A | 2023-06-06 A | 100% |  |  | finish no earlier than 2023-06-06 | S2 | 1024h | 1024h | PIN | 50 | Zhenhua Xie, vivo | Rel-18 | 98 | zhenhua.xie@vivo.com |  |
| 292 | 192.6 | CT1 aspects of PIN |  | 257d | 2023-03-13 A | 2024-03-03 A | 100% |  |  | finish no earlier than 2024-03-03 | C1 | 2056h | 2056h | PIN | 50 | Hui Wang, vivo | Rel-18 | 99 | wanghui.wh@vivo.com |  |
| 293 | 192.7 | CT3 aspects of PIN |  | 257d | 2023-03-13 A | 2024-03-03 A | 100% |  |  | finish no earlier than 2024-03-03 | C3 | 2056h | 2056h | PIN | 50 | Hui Wang, vivo | Rel-18 | 99 | wanghui.wh@vivo.com |  |
| 294 | 192.8 | CT4 aspects of PIN |  | 257d | 2023-03-13 A | 2024-03-03 A | 100% |  |  | finish no earlier than 2024-03-03 | C4 | 2056h | 2056h | PIN | 50 | Hui Wang, vivo | Rel-18 | 99 | wanghui.wh@vivo.com |  |
| 295 | 193 | **Application layer support for Personal IoT Network** |  | 582d | 2021-12-13 A | 2024-03-03 | 99% | 4.97d |  |  |  | 7304h | 3112h | PINAPP | 50 | Huazhang Lv, vivo Mobile Communications Ltd, | Rel-18 | 99 | huazhang.lv@vivo.com |  |
| 296 | 193.1 | Study on Application layer support for Personal IoT Networks |  | 261d | 2021-12-13 A | 2022-12-12 A | 100% |  |  | finish no earlier than 2022-12-12 | S6 | 2088h | 2088h | FS_PINAPP | 48 | Huazhang Lv, vivo Mobile Communications Ltd | Rel-18 | 94 | huazhang.lv@vivo.com |  |
| 297 | 193.2 | Stage 2 of PINAPP |  | 128d | 2022-12-09 A | 2023-06-06 A | 100% |  |  | finish no earlier than 2023-06-06 | S6 | 1024h | 1024h | PINAPP | 50 | Huazhang Lv, vivo Mobile Communications Ltd, | Rel-18 | 98 | huazhang.lv@vivo.com |  |
| 298 | 193.3 | CT1 aspects of PINAPP |  | 257d | 2023-03-13 A | 2024-03-03 | 98% | 5.14d | 523d | finish no earlier than 2024-03-03 | C1 | 2056h |  | PINAPP | 50 | Yizhong ZHANG, vivo | Rel-18 | 99 | yizhong.zhang@vivo.com |  |
| 299 | 193.4 | CT3 aspects of PINAPP |  | 267d | 2023-03-13 A | 2024-03-14 | 99% | 2.67d | 513d | finish no earlier than 2024-03-15 | C3 | 2136h |  | PINAPP | 50 | Yizhong ZHANG, vivo | Rel-18 | 99 | yizhong.zhang@vivo.com |  |
| 300 | 194 | Study on Personal IoT Networks Security Aspects |  | 197d | 2022-06-02 A | 2023-03-03 A | 100% |  |  | finish no earlier than 2023-03-03 | S3 | 1576h | 1576h | FS_PIN_Sec | 49 | Zhenhua Xie, vivo Mobile Communications Co. Ltd | Rel-18 | 96 | zhuenhua.xie@vivo.com |  |
| 301 | 195 | Study on Application Capability Exposure for IoT Platforms |  | 261d | 2021-06-11 A | 2022-06-09 A | 100% |  |  | finish no earlier than 2022-06-12 | S6 | 2088h | 2088h | FS_ACE_IOT | 47 | Mladin, Catalina; Convida Wireless | Rel-18 | 92 | Mladin.Catalina@convidawireless.com |  |
| 302 | 196 | See also IoT_NTN_en under Satellite and LPHP under Verticals | milestone | 0d? | 2016-03-15 A | 2016-03-15 A | 100% |  |  | start no earlier than 2016-03-15 |  |  |  |  |  |  | Rel-18 |  |  |  |
| 303 | 197 | See also " NB-IoT/eMTC requirements for NTN" (UID 950074) under Satellite | milestone | 0d? | 2016-03-15 A | 2016-03-15 A | 100% |  |  | start no earlier than 2016-03-15 |  |  |  |  |  |  | Rel-18 |  |  |  |
| 304 | 198 | Study on network energy savings for NR |  | 254d | 2021-12-13 A | 2022-12-01 A | 100% |  |  | finish no earlier than 2022-12-01 | R1 | 2032h | 2032h | FS_Netw_Energy_NR | 48 | Yi Wang, Huawei | Rel-18 | 94 | wangyi6@huawei.com | RP-223002 |
| 305 | 199 | Study on low-power wake-up signal and receiver for NR |  | 523d | 2021-12-13 A | 2023-12-12 A | 100% |  |  | finish no earlier than 2023-12-12 | R1 | 4184h | 4184h | FS_NR_LPWUS | 48 | Xueming Pan, vivo | Rel-18 | 94 | panxueming@vivo.com | RP-233067 |

Notes:
- 273: 6/10/23: WID:RP-231499->RP-232647
- 274: 6/9/23: Compl:0%->50%; Stat Rep: ->RP-231568; Rapporteur: Thales->Dorin Panaitopol, THALES; Rap eMail: ->dorin.panaitopol@thalesgroup.com; ; 21/9/23: FCD:12/12/2023->08/09/2023; Compl:50%->100%; Stat Rep: RP-231568->RP-232646;
- 275: 7/9/23: WID:RP-230790->RP-231487; 6/10/23: WID:RP-231487->RP-232686; 2/1/24: WID:RP-232686->RP-233856; 2/4/24: WID:RP-233856->RP-240741
- 276: ; 7/6/23: Compl:0%->11%; 6/9/23: FCD:09/09/2023->22/09/2023; Compl:11%->30%; WID: RP-230790->RP-231487; Stat Rep: ->RP-232459; Rapporteur: Inmarsat->Luca Lodigiani, Inmarsat; Rap eMail: ->Luca.lodigiani@inmarsat.com; ; 21/9/23: FCD:22/09/2023->12/12/2...; 2/4/24: 90%->100
- 277: 6/9/23: WID: RP-230790->RP-231487; Stat Rep: ->RP-232459; Rapporteur: Inmarsat->Luca Lodigiani, Inmarsat; Rap eMail: ->Luca.lodigiani@inmarsat.com; ; 21/9/23: FCD:12/12/2023->06/06/2024; Stat Rep: RP-232459->RP-232609; ; 8/12/23: FCD:06/06/2024->12/12...; 14/3/24: FCD:12/12/2023->/24
- 278: 2/1/24: WID:RP-230792->RP-234060; 2/4/24: WID:RP-234060->RP-240451
- 279: ; 7/6/23: Compl:0%->30%; 6/9/23: Compl:30%->60%; WID: RP-230792->RP-231479; Stat Rep: ->RP-232313; Rapporteur: MediaTek->Aijun CAO, MediaTek Inc.; Rap eMail: ->aijun.cao@mediatek.com; ; 8/12/23: Compl:60%->100%; Stat Rep: RP-232313->RP-233258; ; 4/1/2...; 14/3/24: WID: RP-234060->RP-233259; Stat Rep: RP-233258->RP-240450; Rapporteur: Aijun CAO, MediaTek Inc.->Huanren FU, MediaTek Inc.; Rap eMail: aijun.cao@mediatek.com->huanren.fu@mediatek.com; / Impacted TSs and TRs: 36.764
- 280: ; 7/6/23: CD:06/06/2024->06/06/2023; 6/9/23: FCD:06/06/2023->06/06/2024; WID: RP-230792->RP-231479; Stat Rep: ->RP-232313; Rapporteur: MediaTek->Aijun CAO, MediaTek Inc.; Rap eMail: ->aijun.cao@mediatek.com; ; 8/12/23: Stat Rep: RP-232313->RP-233258; ...; 2/4/24: WID:RP-240451->RP-234060
- 281: TS 36.10x, TS 36.10y; RAN4 requirements for REL-17 WI LTE_NBIOT_eMTC_NTN-Core ; 12/7/22: WID:RP-220938->RP-221556; 9/1/23: WID:RP-221556->RP-223437
- 282: TS 36.10x, TS 36.10y; RAN4 requirements for REL-17 WI LTE_NBIOT_eMTC_NTN-Core ; 20/6/22: FCD:15/12/2022->22/12/2022; Stat Rep: ->RP-221555; Rapporteur: MediaTek->Tim Frost, MediaTek Inc.; Rap eMail: ->tim dot frost at mediatek dot com13/7/22: 36.1...;...; 9/1/23: 100%->100 / Impacted TSs and TRs: 36.102; 36.105; 36.108
- 283: TS 36.1XX; RAN4 requirements for REL-17 WI LTE_NBIOT_eMTC_NTN-Core ; 6/6/22: CD:15/06/2023->23/06/2022; 6/6/22: Stat Rep: ->RP-221555; 20/6/22: Rapporteur: MediaTek->Tim Frost, MediaTek Inc.; Rap eMail: ->tim dot frost at mediatek dot com13/7/22: ...;...; ; ; ; ; ; ; ; ; ; ; ; ; ; ; ; ; ; ; ; ; ; ; ; ; ; ; ; ; ; ; ; ; ; ; ; ; ; ; ; ; ; ; ; ; ; 7/6/23: Compl:45%->100% / Impacted TSs and TRs: 36.181
- 284: 17/3/23: Compl:0%->30%; Stat Rep: ->RP-230284; Rapporteur: CMCC->Dan SONG, Danbo Fu (MediaTek), CMCC, MediaTek Inc.; Rap eMail: ->songdan@chinamobile.com, Danbo.Fu@mediatek.com; 17/3/23: 36.521-4 added;; 29/3/23: WID:RP-223064->RP-230285; ...; 21/9/23...; 2/4/24: WID:RP-223064->RP-240147 / Impacted TSs and TRs: 36.521-4
- 285: -
- 286: ; 10/12/21: WID:SP-211055->SP-211505 (chg rapporteur) / Impacted TSs and TRs: 22.261
- 287: 28/7/20: 22.859 added;; 12/9/20: 0%->15; 5/12/20: 15%->50; 19/3/21: FCD:17/03/2021->06/21; 19/3/21: 50%->75; 11/6/21: 75%->90; 13/9/21: 90%->100 / Impacted TSs and TRs: 22.859
- 288: 28/7/20: 22.858 added;; 12/9/20: 0%->30; 5/12/20: 30%->50; 19/3/21: FCD:17/03/2021->06/21; 19/3/21: 50%->75; 11/6/21: 75%->85; 13/9/21: 85%->100 / Impacted TSs and TRs: 22.858
- 289: ; 13/9/21: 0%->85; 10/12/21: 85%->100; 10/12/21: WID:SP-211055->SP-211505 / Impacted TSs and TRs: 22.261
- 290: 21/1/22: 23.700-88 added;; 12/3/22: 0%->20; 4/6/22: 20%->60; 12/9/22: 60%->75; 12/9/22: FCD:12/09/2022->12/22; 10/12/22: 75%->95; 15/3/23: FCD:12/12/2022->03/23; 15/3/23: 95%->100; 15/3/23: WID:SP-211643->SP-230089 / Impacted TSs and TRs: 23.700-88
- 291: 10/1/23: FCD clarified to be June (and not March) by e-mail; 15/3/23: 0%->60; 8/6/23: 60%->100 / Impacted TSs and TRs: 23.501; 23.502; 23.503
- 292: 6/6/23: Compl:0%->50% / Impacted TSs and TRs: 24.501.24.526.29.512.29.513.29.519.29.522.29.525.23.008.29.502.29.503.29.504.29.505.29.244
- 293: 9/6/23: 0%->20 / Impacted TSs and TRs: 24.501.24.526.29.512.29.513.29.519.29.522.29.525.23.008.29.502.29.503.29.504.29.505.29.244
- 294: Impacted TSs and TRs: 24.501.24.526.29.512.29.513.29.519.29.522.29.525.23.008.29.502.29.503.29.504.29.505.29.244
- 296: 7/1/22: 23.700-78 added;; 12/3/22: WID:SP-211515->SP-220095; 12/3/22: 0%->15; 4/6/22: 15%->40; 12/9/22: 40%->60; 12/9/22: FCD:12/09/2022->12/20; 11/12/22: 60%->100; 31/3/23: 24.583 added; / Impacted TSs and TRs: 23.700-78; 24.583
- 297: 17/3/23: FCD:03/03/2023->/23; 17/3/23: 0%->50; 17/3/23: 23.542 added;; 8/6/23: 50%->100 / Impacted TSs and TRs: 23.542
- 298: 6/6/23: Compl:0%->40% / Impacted TSs and TRs: 27.007
- 299: 31/3/23: 29.583 added;; 9/6/23: 5%->10 / Impacted TSs and TRs: 27.007; 29.583
- 300: 13/7/22: 33.882 added;; 12/9/22: 0%->20; 11/12/22: 20%->50; 17/3/23: 50%->60; 8/6/23: 60%->100 / Impacted TSs and TRs: 33.882
- 301: 2/7/21: 23.700-97 added;; 13/9/21: 0%->15; 13/12/21: 15%->40; 12/3/22: 40%->55; 12/3/22: FCD:11/03/2022->6/22; 12/3/22: WID:SP-210478->SP-220093; 4/6/22: 55%->60; 12/9/22: 60%->75; 11/12/22: 75%->75; 17/3/23: 75%->95; 8/6/23: 95%->100 / Impacted TSs and TRs: 23.700-97
- 302: -
- 303: -
- 304: 21/1/22: 38.864 added;; 22/3/22: Stat Rep: ->RP-220296; 5/4/22: WID:RP-213554->RP-220297 ; 6/6/22: Compl:0%->10% 20/6/22: Rapporteur: Huawei->Yi Wang, Huawei; Rap eMail: ->wangyi6@huawei.com12/7/22: WID:RP-220297->RP-221443; 9/12/22: FCD:22/12/2022->...; 29/3/23: WID:RP-221443->RP-230566 / Impacted TSs and TRs: 38.864
- 305: 21/1/22: 38.869 added;; 22/3/22: Stat Rep: ->RP-2205966/6/22: CD:12/12/2023->23/12/20226/6/22: Stat Rep: RP-220596->RP-221270; 20/6/22: Rapporteur: vivo->Xiaodong Shen, vivo Communication Technology; Rap eMail: ->shenxiaodong@vivo.com12/7/22: WID:R...;...; 8/12/23: Compl:85%->100%; Stat Rep: RP-231812->RP-233067; Rapporteur: Xiaodong Shen, vivo Communication Technology->Xueming Pan, vivo; Rap eMail: shenxiaodong@vivo.com->panxueming@vivo.com; / Impacted TSs and TRs: 38.869

| ID | WBS | Task | Type | Duration | Start | Finish | Complete | Remaining | Actual start | Actual finish | Total slack | Constraint | Resources | Work | Actual work | Acronym | PCG approved | WI rapporteur name | Release | TSG approved | WI rapporteur e-mail | Status Report |
| --- | --- | --- | --- | --- | --- | --- | --- | --- | --- | --- | --- | --- | --- | --- | --- | --- | --- | --- | --- | --- | --- | --- |
| 306 | 200 | **Enhanced support of reduced capability NR devices** |  | 1049d | 2021-12-12 A | 2025-12-12 | 49% | 536.15d |  |  | 57d |  |  | 11592h | 4208h | NR_redcap_enh | 49 | Ericsson | Rel-18 | 97 |  |  |
| 307 | 200.1 | Core part: Enhanced support of reduced capability NR devices |  | 330d | 2022-09-08 A | 2023-12-12 A | 100% |  |  |  |  | finish no earlier than 2023-12-12 | R1 | 2640h | 2640h | NR_redcap_enh-Core | 49 | Johan BERGMAN, Ericsson | Rel-18 | 97 | johan.bergman@ericsson.com | RP-233636 |
| 308 | 200.2 | Perf. part: Enhanced support of reduced capability NR devices |  | 456d | 2022-09-13 A | 2024-06-06 | 40% | 273.6d |  |  | 453d | finish no earlier than 2024-06-06 | R1 | 3648h |  | NR_redcap_enh-Perf | 49 | Johan BERGMAN, Ericsson | Rel-18 | 97 | johan.bergman@ericsson.com | RP-240463 |
| 309 | 200.3 | Study on further NR RedCap (reduced capability) UE complexity reduction |  | 196d | 2021-12-12 A | 2022-09-09 A | 100% |  |  |  |  | finish no earlier than 2022-09-09 | R1 | 1568h | 1568h | FS_NR_redcap_enh | 48 | Johan BERGMAN, Ericsson | Rel-18 | 94 | johan.bergman@ericsson.com | RP-221160 |
| 310 | 200.4 | UE Conformance - Enhanced support of reduced capability NR devices plus CT1 aspects |  | 467d | 2024-03-03 | 2025-12-12 |  |  |  |  | 57d | finish no earlier than 2025-12-12 | R5 | 3736h |  | NR_redcap_enh_plus_CT1-UEConTest |  | China Unicom | Rel-18 |  |  |  |
| 311 | 201 | Study on RedCap Phase 2 |  | 256d | 2021-12-20 A | 2022-12-12 A | 100% |  |  |  |  | finish no earlier than 2022-12-12 | S2 | 2048h | 2048h | FS_REDCAP_Ph2 | 48 | Qian, Chen, Ericsson | Rel-18 | 94 | qian.xb.chen@ericsson.com |  |
| 312 | 202 | **NR RedCap UE with long eDRX for RRC_INACTIVE State** |  | 261d | 2022-12-15 | 2023-12-13 | 100% |  | 2022-09-12 | 2023-12-12 |  |  |  | 5150h | 5150h | NR_REDCAP_Ph2 | 49 | Qian, Chen, Ericsson | Rel-18 | 97 | qian.xb.chen@ericsson.com |  |
| 313 | 202.1 | (Stage 2 of) NR RedCap UE with long eDRX for RRC_INACTIVE State |  | 124.75d | 2022-09-12 A | 2023-03-03 A | 100% |  |  |  |  | finish no earlier than 2023-03-03 | S2 | 998h | 998h | NR_REDCAP_Ph2 | 49 | Qian, Chen, Ericsson | Rel-18 | 97 | qian.xb.chen@ericsson.com |  |
| 314 | 202.2 | CT4 aspects of NR_REDCAP_Ph2 |  | 260d | 2022-12-15 A | 2023-12-12 A | 100% |  |  |  |  |  | C4 | 2080h | 2080h | NR_REDCAP_Ph2 | 49 | Frank Yong Yang, Ericsson | Rel-18 | 97 | frank.yong.yang@ericsson.com |  |
| 315 | 202.3 | CT1 aspects of NR_REDCAP_Ph2 |  | 259d | 2022-12-16 A | 2023-12-12 A | 100% |  |  |  |  | finish no earlier than 2023-12-12 | C1 | 2072h | 2072h | NR_REDCAP_Ph2 | 49 | Frank Yong Yang, Ericsson | Rel-18 | 97 | frank.yong.yang@ericsson.com |  |
| 316 | 203 | **Adding new NR FDD bands for RedCap (Reduced Capability) in Rel-18** |  | 203d | 2023-03-06 A | 2023-12-12 A | 100% |  |  |  |  |  | R4 | 3248h | 3248h | NR_FDD_bands_R18_redcap | 50 | Ericsson | Rel-18 | 99 |  |  |
| 317 | 203.1 | Core part: Adding new NR FDD bands for RedCap (Reduced Capability) in Rel-18 |  | 203d | 2023-03-06 A | 2023-12-12 A | 100% |  |  |  |  | finish no earlier than 2023-12-12 | R4 | 1624h | 1624h | NR_FDD_bands_R18_redcap-Core | 50 | Chunhui Zhang, Ericsson | Rel-18 | 99 | Chunhui.Zhang@ericsson.com | RP-232xyz |
| 318 | 204 | **Network energy savings for NR** |  | 391d | 2022-12-13 A | 2024-06-06 | 67% | 128.63d |  |  | 453d |  |  | 5216h | 2096h | Netw_Energy_NR | 50 | Huawei | Rel-18 | 98 |  |  |
| 319 | 204.1 | Core part: Network energy savings for NR |  | 262d | 2022-12-13 A | 2023-12-12 A | 100% |  |  |  |  | finish no earlier than 2023-12-12 | R1 | 2096h | 2096h | Netw_Energy_NR-Core | 50 | Yi Wang, Huawei | Rel-18 | 98 | wangyi6@huawei.com | RP-233655 |
| 320 | 204.2 | Perf. part: Network energy savings for NR |  | 390d | 2022-12-14 A | 2024-06-06 | 45% | 214.5d |  |  | 453d | finish no earlier than 2024-06-06 | R4 | 3120h |  | Netw_Energy_NR-Perf | 50 | Yi Wang, Huawei | Rel-18 | 98 | wangyi6@huawei.com | RP-240410 |
| 321 | 205 | Rel-18 Uncrewed Aerial Vehicles (UAV), UAS, UAM | milestone | 0d? | 2016-03-15 A | 2016-03-15 A | 100% |  |  |  |  | start no earlier than 2016-03-15 |  |  |  |  |  |  | Rel-18 |  |  |  |
| 322 | 206 | **Further Architecture Enhancement for UAV and UAM** |  | 577d | 2021-12-20 A | 2024-03-03 | 99% | 1.7d |  |  | 523d |  |  | 13896h | 11840h | UAS_Ph2 | 50 | Faccin, Stefano, Qualcomm Incorporated | Rel-18 | 99 | sfaccin@qti.qualcomm.com |  |
| 323 | 206.1 | Study on Phase 2 of UAS, UAV and UAM |  | 256d | 2021-12-20 A | 2022-12-12 A | 100% |  |  |  |  | finish no earlier than 2022-12-12 | S2 | 2048h | 2048h | FS_UAS_Ph2 | 48 | Stefano Faccin | Rel-18 | 94 | sfaccin@qti.qualcomm.com |  |
| 324 | 206.2 | (Stage 2 of UAS Ph2) Further Architecture Enhancement for UAV and UAM |  | 128d | 2022-12-09 A | 2023-06-06 A | 100% |  |  |  |  | finish no earlier than 2023-06-06 | S2 | 1024h | 1024h | UAS_Ph2 | 50 | Faccin, Stefano, Qualcomm Incorporated | Rel-18 | 98 | sfaccin@qti.qualcomm.com |  |
| 325 | 206.3 | Study on Security of Phase 2 for UAS, UAV and UAM |  | 197d | 2022-06-02 A | 2023-03-03 A | 100% |  |  |  |  | finish no earlier than 2023-03-03 | S3 | 1576h | 1576h | FS_UAS_Ph2_SEC | 49 | Escott, Adrian, Qualcomm Incorporated, | Rel-18 | 96 | aescott@qti.qualcomm.com |  |
| 326 | 206.4 | Security of UAV and UAM Phase 2 |  | 128d | 2023-03-16 A | 2023-09-09 A | 100% |  |  |  |  | finish no earlier than 2023-09-09 | S3 | 1024h | 1024h | UAS_Ph2 | 50 | Escott, Adrian, Qualcomm Incorporated | Rel-18 | 99 | aescott@qti.qualcomm.com |  |
| 327 | 206.5 | CT1 aspects of UAS Ph2 |  | 257d | 2023-03-13 A | 2024-03-03 | 98% | 5.14d |  |  | 523d | finish no earlier than 2024-03-03 | C1 | 2056h |  | UAS_Ph2 | 50 | Kim, Sunghoon, Qualcomm Incorporated | Rel-18 | 99 | sunghoon@qti.qualcomm.com |  |
| 328 | 206.6 | CT3 aspects of UAS Ph2 |  | 257d | 2023-03-13 A | 2024-03-03 A | 100% |  |  |  |  | finish no earlier than 2024-03-03 | C3 | 2056h | 2056h | UAS_Ph2 | 50 | Kim, Sunghoon, Qualcomm Incorporated | Rel-18 | 99 | sunghoon@qti.qualcomm.com |  |
| 329 | 206.7 | CT4 aspects of UAS Ph2 |  | 257d | 2023-03-13 A | 2024-03-03 A | 100% |  |  |  |  | finish no earlier than 2024-03-03 | C4 | 2056h | 2056h | UAS_Ph2 | 50 | Kim, Sunghoon, Qualcomm Incorporated | Rel-18 | 99 | sunghoon@qti.qualcomm.com |  |
| 330 | 206.8 | CT6 aspects of UAS Ph2 |  | 257d | 2023-03-13 A | 2024-03-03 A | 100% |  |  |  |  | finish no earlier than 2024-03-03 | C6 | 2056h | 2056h | UAS_Ph2 | 50 | Kim, Sunghoon, Qualcomm Incorporated | Rel-18 | 99 | sunghoon@qti.qualcomm.com |  |
| 331 | 207 | Study on enhanced architecture for UAS Applications |  | 326d | 2021-09-13 A | 2022-12-12 A | 100% |  |  |  |  | finish no earlier than 2022-12-12 | S6 | 2608h | 2608h | FS_eUASAPP | 47 | Monrad, Atle, InterDigital | Rel-18 | 93 | atle.monrad@interdigital.com |  |

Notes:
- 306: 9/1/23: WID:RP-222675->RP-223544; 6/10/23: WID:RP-223544->RP-232671; 2/1/24: WID:RP-232671->RP-233637
- 307: 9/12/22: FCD:10/12/2023->01/12/2023; Compl:0%->15%; Stat Rep: ->RP-222827; Rapporteur: Ericsson->Johan BERGMAN, Ericsson; Rap eMail: ->johan.bergman@ericsson.com; 17/3/23: FCD:30/11/2023->12/12/2023; Compl:15%->30%; Stat Rep: RP-222827->RP-230111; ;.....; 8/12/23: Compl:75%->100%; Stat Rep: RP-231628->RP-233636;
- 308: 9/12/22: WG: R4->R1; FCD:10/06/2023->01/06/2024; Stat Rep: ->RP-222827; Rapporteur: Ericsson->Johan BERGMAN, Ericsson; Rap eMail: ->johan.bergman@ericsson.com; 17/3/23: Stat Rep: RP-222827->RP-230111; ...; 6/9/23: FCD:06/06/2023->06/06/2024; Stat Rep:...; 14/3/24: Compl:0%->40%; Stat Rep: RP-233636->RP-240463;
- 309: TR 38.8xx; compare REL-17 SI FS_NR_redcap and REL-17 WI NR_redcap; 21/1/22: 38.865 added;; 22/3/22: Stat Rep: ->RP-220470 ; 6/6 ; 20/6/22: Rapporteur: Ericsson->Johan BERGMAN, Ericsson; Rap eMail: ->johan.bergman@ericsson.com12/7/22: WID:RP-213661-...; 23/9/22: 0%->100 / Impacted TSs and TRs: 38.865
- 311: 21/01/22: name corrected; 21/1/22: 23.700-68 added;; 12/3/22: 0%->30; 12/3/22: WID:SP-211635->SP-220074; 4/6/22: 30%->70; 12/9/22: 70%->99; 12/9/22: FCD:12/09/2022->12/22; 10/12/22: 99%->100 / Impacted TSs and TRs: 23.700-68
- 312: Impacted TSs and TRs: 23.501; 23.502
- 313: ; 10/12/22: 0%->60; 15/3/23: WID:SP-220803->SP-230171; 15/3/23: 60%->95; 8/6/23: 95%->100; 4/1/24: 28.876 added; / Impacted TSs and TRs: 23.501; 23.502 ; 28.876
- 314: 6/6/23: Compl:60%->90% / Impacted TSs and TRs: 24.008; 29.502; 29.518
- 315: Impacted TSs and TRs: 24.008; 29.502; 29.518
- 316: 2/1/24: WID:RP-230743->RP-232894
- 317: ; 7/6/23: Compl:0%->40%; 6/9/23: Compl:40%->50%; WID: RP-230743->RP-231049; Stat Rep: ->RP-231881; Rapporteur: Ericsson->Chunhui Zhang, Ericsson; Rap eMail: ->Chunhui.Zhang@ericsson.com; ; 8/12/23: Compl:50%->100%; Stat Rep: RP-231881->RP-232xyz;
- 318: 2/1/24: WID:RP-223540->RP-234009
- 319: 17/3/23: FCD:12/12/2023->08/09/2023; Compl:0%->15%; Stat Rep: ->RP-230565; Rapporteur: Huawei->Yi Wang, Huawei; Rap eMail: ->wangyi6@huawei.com; 31/3/23: FCD:08/09/2023->12/12/2023; Stat Rep: RP-230565->RP-230714; ;...; 6/9/23: Compl:55%->75%; Stat Re...; 8/12/23: Compl:75%->100%; Stat Rep: RP-231926->RP-233655;
- 320: 17/3/23: Stat Rep: ->RP-230565; Rapporteur: Huawei->Yi Wang, Huawei; Rap eMail: ->wangyi6@huawei.com; 31/3/23: FCD:06/06/2024->06/06/2023; Stat Rep: RP-230565->RP-230714; ...; 6/9/23: FCD:06/06/2023->06/06/2024; Stat Rep: RP-230714->RP-231926; ; 8/12/...; 14/3/24: FCD:05/06/2024->06/06/2024; Compl:15%->45%; Stat Rep: RP-233655->RP-240410;
- 321: -
- 322: 10/1/23: FCD clarified to be June (and not March) by e-mail / Impacted TSs and TRs: 23.256
- 323: ; 21/1/22: 23.700-58 added;; 12/3/22: 0%->20; 4/6/22: 20%->50; 4/6/22: FCD:10/06/2022->09/22; 12/9/22: 50%->80; 12/9/22: FCD:12/09/2022->12/22; 10/12/22: 80%->98; 15/3/23: 98%->100 / Impacted TSs and TRs: 23.256 ; 23.700-58
- 324: 10/1/23: FCD clarified to be June (and not March) by e-mail ; 15/3/23: 0%->85; 15/3/23: WID:SP-221323->SP-230091; 8/6/23: 85%->100 / Impacted TSs and TRs: 23.256
- 325: 13/7/22: 33.891 added;; 11/12/22: 0%->65; 17/3/23: 65%->100 / Impacted TSs and TRs: 33.891
- 326: ; 8/6/23: 0%->60; 7/9/23: 60%->100 / Impacted TSs and TRs: 33.256
- 327: 31/3/23: 24.578 added;; 31/3/23: 24.577 added;6/6/23: Compl:0%->50% / Impacted TSs and TRs: 24.501.23.122.24.587.27.007.29.255.29.513.29.519.29.522.29.525.29.256.23.008.29.503.29.505.29.510.29.518.29.571.31.102; 24.578; 24.577
- 328: 9/6/23: 0%->30 / Impacted TSs and TRs: 24.501.23.122.24.587.27.007.29.255.29.513.29.519.29.522.29.525.29.256.23.008.29.503.29.505.29.510.29.518.29.571.31.102
- 329: 6/6/23: Compl:0%->10% / Impacted TSs and TRs: 24.501.23.122.24.587.27.007.29.255.29.513.29.519.29.522.29.525.29.256.23.008.29.503.29.505.29.510.29.518.29.571.31.102
- 330: Impacted TSs and TRs: 24.501.23.122.24.587.27.007.29.255.29.513.29.519.29.522.29.525.29.256.23.008.29.503.29.505.29.510.29.518.29.571.31.102
- 331: 13/12/21: 0%->10; 13/12/21: WID:SP-210954->SP-211511; 13/12/21: FCD:Fri 10/06/->09/22; 12/3/22: 10%->30; 12/3/22: WID:SP-211511->SP-22009; 22/3/22: 23.700-55 added;; 4/6/22: 30%->50; 4/6/22: WID:SP-22009->SP-220465; 12/9/22: 50%->80; 12/9/22: FCD:12/09...; 11/12/22: 80%->100 / Impacted TSs and TRs: 23.700-55

| ID | WBS | Task | Type | Duration | Start | Finish | Complete | Remaining | Actual start | Total slack | Constraint | Resources | Work | Actual work | Acronym | PCG approved | WI rapporteur name | WI rapporteur e-mail | Release | TSG approved | Status Report |
| --- | --- | --- | --- | --- | --- | --- | --- | --- | --- | --- | --- | --- | --- | --- | --- | --- | --- | --- | --- | --- | --- |
| 332 | 208 | **Architecture for UAS Applications, Phase 2** |  | 329d | 2022-09-09 A | 2023-12-12 A | 100% |  |  |  |  |  | 5688h | 5688h | UASAPP_Ph2 | 49 | Monrad, Atle, InterDigital | atle.monrad@interdigital.com | Rel-18 | 97 |  |
| 333 | 208.1 | Stage 2 of UASAPP_Ph2 |  | 193d | 2022-09-09 A | 2023-06-06 A | 100% |  |  |  | finish no earlier than 2023-06-06 | S6 | 1544h | 1544h | UASAPP_Ph2 | 49 | Monrad, Atle, InterDigital | atle.monrad@interdigital.com | Rel-18 | 97 |  |
| 334 | 208.2 | CT1 aspects of UASAPP_Ph2 |  | 259d | 2022-12-16 A | 2023-12-12 A | 100% |  |  |  | finish no earlier than 2023-12-12 | C1 | 2072h | 2072h | UASAPP_Ph2 | 49 | Taimoor Abbas, InterDigital | taimoor.abbas@interdigital.com | Rel-18 | 97 |  |
| 335 | 208.3 | CT3 aspects of UASAPP_Ph2 |  | 259d | 2022-12-16 A | 2023-12-12 A | 100% |  |  |  | finish no earlier than 2023-12-12 | C3 | 2072h | 2072h | UASAPP_Ph2 | 49 | Taimoor Abbas, InterDigital | taimoor.abbas@interdigital.com | Rel-18 | 97 |  |
| 336 | 209 | **NR support for UAV (Uncrewed Aerial Vehicles)** |  | 523d | 2021-12-13 A | 2023-12-12 A | 100% |  |  |  |  | R2 | 8368h | 8368h | NR_UAV | 48 | Nokia |  | Rel-18 | 94 |  |
| 337 | 209.1 | Core part: NR support for UAV (Uncrewed Aerial Vehicles) |  | 523d | 2021-12-13 A | 2023-12-12 A | 100% |  |  |  | finish no earlier than 2023-12-12 | R2 | 4184h | 4184h | NR_UAV-Core | 48 | Jedrzej Stanczak, Nokia, Nokia Shanghai Bell | jedrzej.stanczak@nokia.com | Rel-18 | 94 | RP-233385 |
| 338 | 210 | **Enhanced LTE Support for UAV (Uncrewed Aerial Vehicles)** |  | 204d | 2023-03-03 A | 2023-12-12 A | 100% |  |  |  |  | R2 | 3264h | 3264h | LTE_UAV_enh | 50 | Nokia |  | Rel-18 | 99 |  |
| 339 | 210.1 | Core part: Enhanced LTE Support for UAV (Uncrewed Aerial Vehicles) |  | 204d | 2023-03-03 A | 2023-12-12 A | 100% |  |  |  | finish no earlier than 2023-12-12 | R2 | 1632h | 1632h | LTE_UAV_enh-Core | 50 | Jedrzej Stanczak, Nokia, Nokia Shanghai Bell | jedrzej.stanczak@nokia.com | Rel-18 | 99 | RP-233388 |
| 340 | 211 | Rel-18 Sidelink, Proximity, Location and Positioning | milestone | 0d? | 2016-03-15 A | 2016-03-15 A | 100% |  |  |  | start no earlier than 2016-03-15 |  |  |  |  |  |  |  | Rel-18 |  |  |
| 341 | 212 | **Ranging-based Service and sidelink positioning** |  | 965d | 2020-06-25 A | 2024-03-03 | 99% | 12.46d |  | 523d |  |  | 15904h | 9736h | Ranging | 46 | Xiaowei jiang, Xiaomi | jiangxiaowei@xiaomi.com | Rel-18 | 91 |  |
| 342 | 212.1 | Study on Ranging |  | 252d | 2020-06-25 A | 2021-06-11 A | 100% |  |  |  | finish no earlier than 2021-06-12 | S1 | 2016h | 2016h | FS_Ranging | 45 | Xiaowei jiang | jiangxiaowei@xiaomi.com | Rel-18 | 88 |  |
| 343 | 212.2 | Stage 1 for Ranging |  | 62d | 2021-03-18 A | 2021-06-11 A | 100% |  |  |  | finish no earlier than 2021-06-12 | S1 | 496h | 496h | Ranging | 46 | Xiaowei jiang, Xiaomi | jiangxiaowei@xiaomi.com | Rel-18 | 91 |  |
| 344 | 212.3 | Study on Ranging based services and sidelink positioning |  | 256d | 2021-12-20 A | 2022-12-12 A | 100% |  |  |  | finish no earlier than 2022-12-12 | S2 | 2048h | 2048h | FS_Ranging_SL | 48 | Shen, Sherry (Yang), Xiaomi, | shenyang6@xiaomi.com | Rel-18 | 94 |  |
| 345 | 212.4 | Stage 2 of Ranging_SL |  | 128d | 2022-12-09 A | 2023-06-06 A | 100% |  |  |  | finish no earlier than 2023-06-06 | S2 | 1024h | 1024h | Ranging_SL | 50 | Shen, Sherry (Yang), Xiaomi | shenyang6@xiaomi.com | Rel-18 | 98 |  |
| 346 | 212.5 | Study on Security Aspects of Ranging Based Services and Sidelink Positioning |  | 197d | 2022-06-02 A | 2023-03-03 A | 100% |  |  |  | finish no earlier than 2023-03-03 | S3 | 1576h | 1576h | FS_Ranging_SL_Sec | 49 | Wei Lu, Xiaomi, | luwei10@xiaomi.com | Rel-18 | 96 |  |
| 347 | 212.6 | Security Aspects of Ranging_SL |  | 128d | 2023-03-16 A | 2023-09-09 A | 100% |  |  |  | finish no earlier than 2023-09-09 | S3 | 1024h | 1024h | Ranging_SL_Sec | 50 | Lu, Wei, Xiaomi | luwei10@xiaomi.com | Rel-18 | 99 |  |
| 348 | 212.7 | CT1 aspects of Ranging_SL |  | 257d | 2023-03-13 A | 2024-03-03 | 96% | 10.28d |  | 523d | finish no earlier than 2024-03-03 | C1 | 2056h |  | Ranging_SL | 50 | Tingfang Tang, Xiaomi | tangtingfang@xiaomi.com | Rel-18 | 99 |  |
| 349 | 212.8 | CT3 aspects of Ranging_SL |  | 257d | 2023-03-13 A | 2024-03-03 | 96% | 10.28d |  | 523d | finish no earlier than 2024-03-03 | C3 | 2056h |  | Ranging_SL | 50 | Tingfang Tang, Xiaomi | tangtingfang@xiaomi.com | Rel-18 | 99 |  |
| 350 | 212.9 | CT4 aspects of Ranging_SL |  | 257d | 2023-03-13 A | 2024-03-03 | 98% | 5.14d |  | 523d | finish no earlier than 2024-03-03 | C4 | 2056h |  | Ranging_SL | 50 | Tingfang Tang, Xiaomi | tangtingfang@xiaomi.com | Rel-18 | 99 |  |
| 351 | 212.10 | Charging Aspects of Ranging and Sidelink Positioning |  | 194d | 2023-06-08 A | 2024-03-03 A | 100% |  |  |  | finish no earlier than 2024-03-03 | S5 | 1552h | 1552h | FS_Ranging_SL_CH | 51 | Zhiwei Mo, China Telecom, | mozw<at>chinatelecom<dot>cn | Rel-18 | 100 |  |
| 352 | 213 | **5GC LoCation Services - Phase 3** |  | 373d | 2022-09-30 | 2024-03-03 | 97% | 12.82d | 2021-12-20 |  |  |  | 11104h | 6016h | 5G_eLCS_Ph3 | 49 | Ming Ai, CATT | aiming@catt.cn | Rel-18 | 97 |  |
| 353 | 213.1 | Study on Enhancement to the 5GC LoCation Services-Phase 3 |  | 256d | 2021-12-20 A | 2022-12-12 A | 100% |  |  |  | finish no earlier than 2022-12-12 | S2 | 2048h | 2048h | FS_eLCS_Ph3 | 48 | Ming Ai, CATT | aiming@catt.cn, Primary Rapporteur. | Rel-18 | 94 |  |
| 354 | 213.2 | (stage 2 of) 5GC LoCation Services - Phase 3 |  | 178d | 2022-09-30 A | 2023-06-06 A | 100% |  |  |  | finish no earlier than 2023-06-06 | S2 | 1424h | 1424h | 5G_eLCS_Ph3 | 49 | Ming Ai, CATT | aiming@catt.cn | Rel-18 | 97 |  |
| 355 | 213.3 | CT1 aspects of 5G_eLCS_Ph3 |  | 318d | 2022-12-16 A | 2024-03-03 | 90% | 31.8d |  | 523d | finish no earlier than 2024-03-03 | C1 | 2544h |  | 5G_eLCS_Ph3 | 49 | Wang, Baixiao, CATT | wangbaixiao@cictmobile.com | Rel-18 | 97 |  |
| 356 | 213.4 | CT3 aspects of 5G_eLCS_Ph3 |  | 318d | 2022-12-16 A | 2024-03-03 A | 100% |  |  |  | finish no earlier than 2024-03-03 | C3 | 2544h | 2544h | 5G_eLCS_Ph3 | 49 | Wang, Baixiao, CATT | wangbaixiao@cictmobile.com | Rel-18 | 97 |  |
| 357 | 213.5 | CT4 aspects of 5G_eLCS_Ph3 |  | 318d | 2022-12-16 A | 2024-03-03 | 95% | 15.9d |  | 523d | finish no earlier than 2024-03-03 | C4 | 2544h |  | 5G_eLCS_Ph3 | 49 | Wang, Baixiao, CATT | wangbaixiao@cictmobile.com | Rel-18 | 97 |  |
| 358 | 214 | Study on expanded and improved NR positioning |  | 390d | 2022-12-13 A | 2024-06-06 A | 100% |  |  |  |  | R1 | 3120h | 3120h | FS_NR_pos_enh2 | 48 | Debdeep Chatterjee, Intel Corporation | debdeep.chatterjee@intel.com | Rel-18 | 94 | RP-222982 |

Notes:
- 332: Impacted TSs and TRs: 23.255
- 333: ; 11/12/22: 0%->25; 9/1/23: WID:SP-220915->SP-221228; 17/3/23: 25%->65; 17/3/23: FCD:03/03/2023->/23; 8/6/23: 65%->100 / Impacted TSs and TRs: 23.255
- 334: 6/6/23: Compl:5%->60% / Impacted TSs and TRs: 27.007; 24.257; 29.257
- 335: ; 9/6/23: 0%->40 / Impacted TSs and TRs: 27.007; 24.257; 29.257
- 336: no Perf. part; no RAN1 spec affected so far; 9/1/23: WID:RP-213600->RP-223545; 29/3/23: WID:RP-223545->RP-230782; 2/1/24: WID:RP-230782->RP-233386
- 337: no Perf. part; no RAN1 spec affected so far; 20/6/22: FCD:12/12/2023->23/12/2022; Stat Rep: ->RP-221498; Rapporteur: Nokia->Jedrzej Stanczak, Nokia, Nokia Shanghai Bell; Rap eMail: ->jedrzej.stanczak@nokia.com13/7/22: FCD:23/12/2022->12/20...; 17/3/23:...; 8/12/23: Compl:80%->100%; Stat Rep: RP-231864->RP-233385;
- 338: 2/1/24: WID:RP-230783->RP-233389
- 339: ; 7/6/23: Compl:0%->60%; 6/9/23: Compl:60%->80%; Stat Rep: ->RP-231865; Rapporteur: Nokia->Jedrzej Stanczak, Nokia, Nokia Shanghai Bell; Rap eMail: ->jedrzej.stanczak@nokia.com; ; 8/12/23: Compl:80%->100%; Stat Rep: RP-231865->RP-233388;
- 340: -
- 341: Impacted TSs and TRs: 22.261
- 342: 28/7/20: 22.855 added;; 12/9/20: 0%->40; 5/12/20: 40%->80; 19/3/21: FCD:17/03/2021->06/21; 19/3/21: 80%->85; 11/6/21: 85%->100 / Impacted TSs and TRs: 22.855
- 343: ; 11/6/21: 0%->100 / Impacted TSs and TRs: 22.261
- 344: 21/1/22: 23.700-86 added;; 12/3/22: 0%->15; 4/6/22: 15%->60; 12/9/22: 60%->70; 10/12/22: 70%->85; 15/3/23: 85%->100 / Impacted TSs and TRs: 23.700-86
- 345: "Architecture Enhancement to support Ranging based services and Sidelink Positioning" ; 15/3/23: 0%->50; 15/3/23: WID:SP-221325->SP-230106; 17/3/23: 23.586 added;; 8/6/23: 50%->100 / Impacted TSs and TRs: 23.304; 23.287; 23.273; 23.502; 23.503 ; 23.586
- 346: 13/7/22: 33.893 added;; 12/9/22: 0%->20; 11/12/22: 20%->40; 17/3/23: 40%->70; 8/6/23: 70%->100 / Impacted TSs and TRs: 33.893
- 347: 31/3/23: 33.533 added;; 8/6/23: 0%->40; 30/6/23: WID:SP-230159->SP-230769; 7/9/23: 40%->100 / Impacted TSs and TRs: 33.533
- 348: ; 31/3/23: 24.514 added;6/6/23: Compl:0%->15% / Impacted TSs and TRs: 24.501.24.554.24.555.24.571.24.587.24.588.29.122.29.522.29.525.29.519.29.503.29.504.29.505.29.510.29.515.29.571.29.572; 24.514
- 349: Impacted TSs and TRs: 24.501.24.554.24.555.24.571.24.587.24.588.29.122.29.522.29.525.29.519.29.503.29.504.29.505.29.510.29.515.29.571.29.572
- 350: 6/6/23: Compl:0%->30%; 4/1/24: 29.586 added; / Impacted TSs and TRs: 24.501.24.554.24.555.24.571.24.587.24.588.29.122.29.522.29.525.29.519.29.503.29.504.29.505.29.510.29.515.29.571.29.572; 29.586
- 351: 30/6/23: 28.845 added;; 7/9/23: 0%->15; 8/12/23: 15%->70; 8/12/23: FCD:12/12/2023->/2024; 14/3/24: 70%->100 / Impacted TSs and TRs: 28.845
- 352: Impacted TSs and TRs: 23.273
- 353: 21/1/22: 23.700-71 added;; 12/3/22: 0%->15; 12/3/22: WID:SP-211637->SP-220069; 4/6/22: 15%->55; 4/6/22: FCD:12/09/2022->12/22; 12/9/22: 55%->80; 10/12/22: 80%->100 / Impacted TSs and TRs: 23.700-71
- 354: ; 10/12/22: WID:SP-220811->SP-221123; 10/12/22: 0%->30; 10/12/22: 0%->30; 9/1/23: WID:SP-221123->SP-221338; 15/3/23: 30%->65; 15/3/23: WID:SP-221338->SP-230093; 15/3/23: FCD:03/03/2023->06/20; 8/6/23: 65%->100 / Impacted TSs and TRs: 23.273
- 355: 6/6/23: Compl:5%->15% / Impacted TSs and TRs: 23.273
- 356: ; 9/6/23: 20%->30 / Impacted TSs and TRs: 23.273
- 357: ; 9/6/23: 25%->65 / Impacted TSs and TRs: 23.273
- 358: compare REL-17 SI FS_NR_pos; TR 38.8xx; 21/1/22: 38.859 added; ; 6/6/22: Compl:0%->12% 20/6/22: Rapporteur: Intel->Alexey Khoryaev, Intel Corporation; Rap eMail: ->alexey.khoryaev@intel.com12/7/22: WID:RP-213588->RP-221814 ;...; 23/9/22: WID:RP-213588...; 9/1/23: 0%->100 / Impacted TSs and TRs: 38.859

| ID | WBS | Task | Type | Duration | Start | Finish | Complete | Remaining | Total slack | Constraint | Resources | Work | Actual work | Acronym | PCG approved | WI rapporteur name | Release | TSG approved | WI rapporteur e-mail | Status Report |
| --- | --- | --- | --- | --- | --- | --- | --- | --- | --- | --- | --- | --- | --- | --- | --- | --- | --- | --- | --- | --- |
| 359 | 215 | **Expanded and improved NR positioning** |  | 391d | 2022-12-13 A | 2024-06-06 | 64% | 139.44d | 453d |  |  | 5672h | 2560h | NR_pos_enh2 | 50 | Intel | Rel-18 | 98 |  |  |
| 360 | 215.1 | Core part: Expanded and improved NR positioning |  | 320d | 2022-12-13 A | 2024-03-01 A | 100% |  |  | finish no earlier than 2024-03-01 | R1 | 2560h | 2560h | NR_pos_enh2-Core | 50 | Debdeep Chatterjee | Rel-18 | 98 | debdeep.chatterjee@intel.com | RP-240302 |
| 361 | 215.2 | Perf. part: Expanded and improved NR positioning |  | 389d | 2022-12-15 A | 2024-06-06 | 35% | 252.85d | 453d | finish no earlier than 2024-06-06 | R4 | 3112h |  | NR_pos_enh2-Perf | 50 | Debdeep Chatterjee | Rel-18 | 98 | debdeep.chatterjee@intel.com | RP-240302 |
| 362 | 216 | **NR sidelink evolution** |  | 652d | 2021-12-13 A | 2024-06-06 | 67% | 216.78d | 453d |  |  | 9384h | 4184h | NR_SL_enh2 | 48 | OPPO | Rel-18 | 94 |  |  |
| 363 | 216.1 | Core part: NR sidelink evolution |  | 523d | 2021-12-13 A | 2023-12-12 A | 100% |  |  | finish no earlier than 2023-12-12 | R1 | 4184h | 4184h | NR_SL_enh2-Core | 48 | Kevin Lin, OPPO | Rel-18 | 94 | Kevin.Lin@oppo.com | RP-232786 |
| 364 | 216.2 | Perf. part: NR sidelink evolution |  | 650d | 2021-12-15 A | 2024-06-06 | 40% | 390d | 453d | finish no earlier than 2024-06-06 | R1 | 5200h |  | NR_SL_enh2-Perf | 48 | Kevin Lin, OPPO | Rel-18 | 94 | Kevin.Lin@oppo.com | RP-240065 |
| 365 | 217 | **NR sidelink relay enhancements** |  | 719d | 2021-12-13 A | 2024-09-09 | 57% | 312.62d | 386d |  |  | 14080h | 4184h | NR_SL_relay_enh | 48 | LG Electronics | Rel-18 | 94 |  |  |
| 366 | 217.1 | Core part: NR sidelink relay enhancements |  | 523d | 2021-12-13 A | 2023-12-12 A | 100% |  |  | finish no earlier than 2023-12-12 | R2 | 4184h | 4184h | NR_SL_relay_enh-Core | 48 | Youngdae LEE, LG Electronics Inc. | Rel-18 | 94 | youngdae.lee@lge.com | RP-232971 |
| 367 | 217.2 | Perf. part: NR sidelink relay enhancements |  | 650d | 2021-12-15 A | 2024-06-06 | 50% | 325d | 453d | finish no earlier than 2024-06-06 | R2 | 5200h |  | NR_SL_relay_enh-Perf | 48 | Youngdae LEE, LG Electronics Inc. | Rel-18 | 94 | youngdae.lee@lge.com | RP-240128 |
| 368 | 217.3 | UE Conformance - NR Sidelink Relay |  | 587d | 2022-06-15 A | 2024-09-09 | 25% | 440.25d | 386d | finish no earlier than 2024-09-09 | R5 | 4696h |  | NR_SL_relay-UEConTest | 49 | Xiaozhong CHEN, CATT | Rel-17 | 96 | chenxiaozhong@catt.cn | RP-240388 |
| 369 | 218 | **Mobile Terminated-Small Data Transmission (MT-SDT) for NR** |  | 523d | 2021-12-13 A | 2023-12-12 A | 100% |  |  |  |  | 4184h | 4184h | NR_MT_SDT | 48 | ZTE | Rel-18 | 94 |  |  |
| 370 | 218.1 | Core part: Mobile Terminated-Small Data Transmission (MT-SDT) for NR |  | 523d | 2021-12-13 A | 2023-12-12 A | 100% |  |  | finish no earlier than 2023-12-12 | R2 | 4184h | 4184h | NR_MT_SDT-Core | 48 | Eswar Vutukuri, ZTE Corporation | Rel-18 | 94 | eswar.vutukuri@zte.com.cn | RP-232887 |
| 371 | 219 | **Study on Proximity based Services Phase 2** |  | 320d | 2021-12-20 A | 2023-03-10 A | 100% |  |  |  | S2 | 6704h | 6704h | FS_5G_ProSe_Ph2 | 48 | Deng, Qiang, CATT | Rel-18 | 95 | dengqiang1@catt.cn, Primary Rapporteur. |  |
| 372 | 219.1 | Study on Stage 2 for Proximity based Services Phase 2 |  | 256d | 2021-12-20 A | 2022-12-12 A | 100% |  |  | finish no earlier than 2022-12-12 | S2 | 2048h | 2048h | FS_5G_ProSe_Ph2 | 48 | Deng, Qiang, CATT | Rel-18 | 94 | dengqiang1@catt.cn, Primary Rapporteur. |  |
| 373 | 219.2 | Study on Security Aspects of Proximity Based Services Phase 2 |  | 262d | 2022-03-10 A | 2023-03-10 A | 100% |  |  | finish no earlier than 2023-03-12 | S3 | 2096h | 2096h | FS_5G_ProSe_Ph2 | 48 | Wei Zhou, CATT | Rel-18 | 95 | zhouwei@catt.cn |  |
| 374 | 220 | **Proximity-based Services in 5GS Phase 2** |  | 317d? | 2022-09-27 A | 2023-12-12 | 99% | 1.22d? | 582d |  |  | 10760h | 6616h | 5G_ProSe_Ph2 | 49 | Deng Qiang, CATT | Rel-18 | 97 | dengqiang1@catt.cn |  |
| 375 | 220.1 | (stage 2 of) Proximity-based Services in 5GS Phase 2 |  | 181d? | 2022-09-27 A | 2023-06-06 A | 100% |  |  | finish no earlier than 2023-06-06 | S2 | 1448h | 1448h | 5G_ProSe_Ph2 | 49 | Deng Qiang, CATT | Rel-18 | 97 | dengqiang1@catt.cn |  |
| 376 | 220.2 | CT1 aspects of 5G_ProSe_Ph2 |  | 259d | 2022-12-16 A | 2023-12-12 | 99% | 2.59d | 582d | finish no earlier than 2023-12-12 | C1 | 2072h |  | 5G_ProSe_Ph2 | 49 | Duan, Xiaoyan, CATT | Rel-18 | 97 | duanxiaoyan@catt.cn |  |
| 377 | 220.3 | CT3 aspects of 5G_ProSe_Ph2 |  | 259d | 2022-12-16 A | 2023-12-12 A | 100% |  |  | finish no earlier than 2023-12-12 | C3 | 2072h | 2072h | 5G_ProSe_Ph2 | 49 | Duan, Xiaoyan, CATT | Rel-18 | 97 | duanxiaoyan@catt.cn |  |
| 378 | 220.4 | CT4 aspects of 5G_ProSe_Ph2 |  | 259d | 2022-12-16 A | 2023-12-12 A | 100% |  |  | finish no earlier than 2023-12-12 | C4 | 2072h | 2072h | 5G_ProSe_Ph2 | 49 | Duan, Xiaoyan, CATT | Rel-18 | 97 | duanxiaoyan@catt.cn |  |
| 379 | 220.5 | CT6 aspects of 5G_ProSe_Ph2 |  | 259d | 2022-12-16 A | 2023-12-12 | 99% | 2.59d | 582d | finish no earlier than 2023-12-12 | C6 | 2072h |  | 5G_ProSe_Ph2 | 49 | Duan, Xiaoyan, CATT | Rel-18 | 97 | duanxiaoyan@catt.cn |  |
| 380 | 220.6 | Security Aspects of Proximity-based Services in 5GS Phase 2 |  | 128d | 2023-03-16 A | 2023-09-09 A | 100% |  |  | finish no earlier than 2023-09-09 | S3 | 1024h | 1024h | 5G_ProSe_Ph2 | 50 | Wei Zhou, CATT | Rel-18 | 99 | zhouwei@catt.cn |  |
| 381 | 221 | **5G-enabled fused location service capability exposure** |  | 714d | 2021-06-11 A | 2024-03-03 A | 100% |  |  |  |  | 7752h | 7752h | 5GFLS | 50 | Liping Wu, CATT | Rel-18 | 99 | wuliping@cictmobile.com |  |
| 382 | 221.1 | Study on 5G-enabled fused location service capability exposure |  | 327d | 2021-06-11 A | 2022-09-12 A | 100% |  |  | finish no earlier than 2022-09-12 | S6 | 2616h | 2616h | FS_5GFLS | 47 | Zhang, Ling, CATT | Rel-18 | 92 | zhangling@catt.cn |  |
| 383 | 221.2 | Stage 2 of 5GFLS |  | 128d | 2022-12-09 A | 2023-06-06 A | 100% |  |  | finish no earlier than 2023-06-06 | S6 | 1024h | 1024h | 5GFLS | 50 | Liping Wu, CATT | Rel-18 | 98 | wuliping@cictmobile.com |  |
| 384 | 221.3 | CT1 aspects of 5GFLS |  | 257d | 2023-03-13 A | 2024-03-03 A | 100% |  |  | finish no earlier than 2024-03-03 | C1 | 2056h | 2056h | 5GFLS | 50 | Zhao, Xiaoxue, CATT | Rel-18 | 99 | zhaoxiaoxue@cictmobile.com |  |
| 385 | 221.4 | CT3 aspects of 5GFLS |  | 257d | 2023-03-13 A | 2024-03-03 A | 100% |  |  | finish no earlier than 2024-03-03 | C3 | 2056h | 2056h | 5GFLS | 50 | Zhao, Xiaoxue, CATT | Rel-18 | 99 | zhaoxiaoxue@cictmobile.com |  |
| 386 | 222 | See also MCOver5GProSe under Mission Critical and LPHP under Verticals | milestone | 0d? | 2016-03-15 A | 2016-03-15 A | 100% |  |  | start no earlier than 2016-03-15 |  |  |  |  |  |  | Rel-18 |  |  |  |
| 387 | 223 | Rel-18 Verticals, Industries, Factories, Northbound API | milestone | 0d? | 2016-03-15 A | 2016-03-15 A | 100% |  |  | start no earlier than 2016-03-15 |  |  |  |  |  |  | Rel-18 |  |  |  |
| 388 | 224 | Service exposure interfaces for industry |  | 7d | 2021-09-10 A | 2021-09-20 A | 100% |  |  | finish no earlier than 2021-09-20 | S1 | 56h | 56h | EXPOSE | 47 | Joachim W. Walewski | Rel-18 | 93 | joachim.walewski@siemens.com |  |

Notes:
- 359: 29/3/23: WID:RP-223549->RP-230328; 6/10/23: WID:RP-230328->RP-232670; 2/1/24: WID:RP-232670->RP-233382; 2/4/24: WID:RP-233382->RP-240778
- 360: 17/3/23: Compl:0%->15%; Stat Rep: ->RP-230327; Rapporteur: Intel->Debdeep Chatterjee, Intel Corporation; Rap eMail: ->debdeep.chatterjee@intel.com; 17/3/23: 38.355 added;; ;...; 6/9/23: Compl:50%->70%; WID: RP-230328->RP-231460; Stat Rep: RP-230327->R...; 14/3/24: Compl:99%->100%; Stat Rep: RP-233375->RP-240302; Rapporteur: Debdeep Chatterjee, Intel Corporation->Debdeep Chatterjee; / Impacted TSs and TRs: 38.355
- 361: Study in Rel-17 UID820025; 13/12/21: 0%->15; 12/3/22: 15%->30; 22/3/22: 23.545 added;; 4/6/22: 30%->50; 12/9/22: 50%->55; 11/12/22: 55%->65; 11/12/22: FCD:09/12/2022->/23; 9/1/23: WID:SP-210957->SP-221233; 17/3/23: 65%->75; 8/6/23: 75%->100; 30/6/23: ...; 14/3/24: Compl:0%->35%; Stat Rep: RP-233375->RP-240302; Rapporteur: Debdeep Chatterjee, Intel Corporation->Debdeep Chatterjee;
- 362: TR 38.8xx; compare REL-17 WI NR_SL_enh; 5/4/22: WID:RP-213678->RP-220300; 12/7/22: WID:RP-220300->RP-221798; 23/9/22: WID:RP-221798->RP-221938; 9/1/23: WID:RP-221938->RP-222806; 29/3/23: WID:RP-222806->RP-230077; 2/1/24: WID:RP-230077->RP-232789
- 363: TR 38.8xx; compare REL-17 WI NR_SL_enh; 22/3/22: Stat Rep: ->RP-220320 6/6/22: Compl:0%->7% ; ; 20/6/22: Rapporteur: OPPO->Kevin Lin, OPPO; Rap eMail: ->Kevin.Lin@oppo.com13/7/22: FCD:23/12/2022->12/20 ; ...; 9/12/22: FCD:23/12/2022->01/12/2023; Comp...; 8/12/23: Compl:85%->100%; Stat Rep: RP-231583->RP-232786; / Impacted TSs and TRs: 38.786
- 364: ; 22/3/22: CD:12/09/2023->12/06/2024; 22/3/22: Stat Rep: ->RP-220320 6/6/22: CD:12/06/2024->24/06/2022 6/6/22: ; 20/6/22: WG: R4->R1; Rapporteur: OPPO->Kevin Lin, OPPO; Rap eMail: ->Kevin.Lin@oppo.com13/7/22: FCD:24/06/2022->06/20 ; ...; 9/12/22: FCD...; 14/3/24: FCD:05/06/2024->06/06/2024; Compl:15%->40%; Stat Rep: RP-232786->RP-240065;
- 365: compare REL-17 WI NR_SL_relay; 6/1/22: WID:RP-213585->RP-212819; 5/4/22: WID:RP-212819->RP-221010; 12/7/22: WID:RP-221010->RP-221262; 9/1/23: WID:RP-221262->RP-223501; 2/1/24: WID:RP-223501->RP-232972
- 366: compare REL-17 WI NR_SL_relay; 22/3/22: WID: RP-212819->RP-213585; 22/3/22: Stat Rep: ->RP-220524 ; 6/6/22: CD:12/12/2023->23/12/2022 ; 20/6/22: Rapporteur: LG Electronics->Youngdae LEE, LG Electronics; Rap eMail: ->youngdae.lee@lge.com13/7/22: ...;...; 8/12/23: Compl:80%->100%; Stat Rep: RP-231725->RP-232971;
- 367: ; 22/3/22: CD:24/06/2024->12/06/2024; 22/3/22: WID: RP-212819->RP-213585; 22/3/22: Stat Rep: ->RP-220524 6/6/22: CD:12/06/2024->24/06/2022 20/6/22: WG: R4->R2; FCD:24/06/2022->22/06/2022; Rapporteur: LG Electronics->Youngdae LEE, LG Electronics;...;...; 14/3/24: FCD:05/06/2024->06/06/2024; Compl:10%->50%; WID: RP-232972->RP-223501; Stat Rep: RP-232971->RP-240128;
- 368: 9/9/22: Comp...; 23/9/22: WID:RP-221447->RP-222378; 9/12/22: FCD:23/09/2022->01/09/2023; WID: RP-222378->RP-221447; Stat Rep: ->RP-223141; Rapporteur: CATT->Xiaozhong CHEN, CATT; Rap eMail: ->chenxiaozhong@catt.cn; 17/3/23: FCD:09/09/2023.....; 2/4/24: WID:RP-221447->RP-240390
- 369: no Perf. part; 9/1/23: WID:RP-213583->RP-222993; 2/1/24: WID:RP-222993->RP-234010
- 370: no Perf. part ; 6/6/22: CD:12/09/2023->23/09/2022 6/6/22: Stat Rep: RP-220215->RP-221310; 20/6/22: Rapporteur: ZTE->Eswar Vutukuri, ZTE Corporation; Rap eMail: ->eswar.vutukuri@zte.com.cn13/7/22: FCD:23/09/2022->09/20 ...; 9/12/22: FCD:23/09/2022->01...; 8/12/23: Compl:99%->100%; Stat Rep: RP-232648->RP-232887;
- 371: 21/1/22: 23.700-33 added;; 12/3/22: 0%->20; 14/3/24: 95%->100 / Impacted TSs and TRs: 23.700-33
- 372: 21/1/22: 23.700-33 added;; 12/3/22: 0%->20; 4/6/22: 20%->55; 12/9/22: 55%->75; 10/12/22: 75%->100 / Impacted TSs and TRs: 23.700-33
- 373: 4/6/22: 0%->5; 13/7/22: 33.740 added;; 13/7/22: 33.741 added;; 12/9/22: 5%->40; 11/12/22: 40%->75; 17/3/23: 75%->80; 8/6/23: 80%->90 / Impacted TSs and TRs: 33.740; 33.741
- 374: Impacted TSs and TRs: 23.304; 23.501; 23.502; 23.503
- 375: ; 9/1/23: WID:SP-220806->SP-221206; 15/3/23: WID:SP-221206->SP-230097; 15/3/23: 0%->80; 15/3/23: FCD:03/03/2023->/23; 8/6/23: 80%->100 / Impacted TSs and TRs: 23.304; 23.501; 23.502; 23.503
- 376: ; 9/6/23: 15%->70 / Impacted TSs and TRs: 24.554; 24.555; 23.122; 24.501; 24.526; 24.587; 27.007; 29.513; 29.519; 29.522; 29.525; 29.559; 29.553; 23.008; 29.503; 29.505; 29.510; 29.518; 29.571; 29.509; 31.102
- 377: ; 9/6/23: 0%->20 / Impacted TSs and TRs: 24.554; 24.555; 23.122; 24.501; 24.526; 24.587; 27.007; 29.513; 29.519; 29.522; 29.525; 29.559; 29.553; 23.008; 29.503; 29.505; 29.510; 29.518; 29.571; 29.509; 31.102
- 378: 6/6/23: Compl:0%->30% / Impacted TSs and TRs: 24.554; 24.555; 23.122; 24.501; 24.526; 24.587; 27.007; 29.513; 29.519; 29.522; 29.525; 29.559; 29.553; 23.008; 29.503; 29.505; 29.510; 29.518; 29.571; 29.509; 31.102
- 379: Impacted TSs and TRs: 24.554; 24.555; 23.122; 24.501; 24.526; 24.587; 27.007; 29.513; 29.519; 29.522; 29.525; 29.559; 29.553; 23.008; 29.503; 29.505; 29.510; 29.518; 29.571; 29.509; 31.102
- 380: ; 8/6/23: 0%->90; 8/12/23: 90%->95; 15/3/24: 95%->100 / Impacted TSs and TRs: 33.503
- 381: Impacted TSs and TRs: 23.434
- 382: 2/7/21: 23.700-96 added;; 13/9/21: 0%->20; 13/12/21: 20%->40; 13/12/21: WID:SP-210477->SP-211512; 13/12/21: FCD:Fri 11/03/->06/22; 12/3/22: FCD:10/06/2022->9/22; 12/3/22: WID:SP-211512->SP-220097; 4/6/22: 40%->55; 12/9/22: 55%->75; 11/12/22: 75%->100 / Impacted TSs and TRs: 23.700-96
- 383: ; 17/3/23: 0%->60; 17/3/23: FCD:03/03/2023->/23; 8/6/23: 60%->100 / Impacted TSs and TRs: 23.434
- 384: 6/6/23: Compl:0%->60% / Impacted TSs and TRs: 24.545; 29.549
- 385: ; 9/6/23: 0%->70 / Impacted TSs and TRs: 24.545; 29.549
- 386: -
- 387: -
- 388: ; 13/12/21: 0%->100 / Impacted TSs and TRs: 22.261

| ID | WBS | Task | Duration | Start | Finish | Complete | Remaining | Total slack | Constraint | Resources | Work | Actual work | Acronym | PCG approved | WI rapporteur name | WI rapporteur e-mail | Release | TSG approved |
| --- | --- | --- | --- | --- | --- | --- | --- | --- | --- | --- | --- | --- | --- | --- | --- | --- | --- | --- |
| 389 | 225 | **Generic group management, exposure and communication enhancements** | 577d | 2021-12-20 A | 2024-03-03 A | 100% |  |  |  |  | 9144h | 9144h | GMEC | 49 | Qianghua Zhu, Huawei | zhuqianghua@huawei.com | Rel-18 | 97 |
| 390 | 225.1 | Study on generic group management, exposure and communication enhancements | 256d | 2021-12-20 A | 2022-12-12 A | 100% |  |  | finish no earlier than 2022-12-12 | S2 | 2048h | 2048h | FS_GMEC | 48 | Qianghua Zhu, Huawei | zhuqianghua@huawei.com | Rel-18 | 94 |
| 391 | 225.2 | Stage 2 of GMEC | 116d | 2022-09-23 A | 2023-03-03 A | 100% |  |  | finish no earlier than 2023-03-03 | S2 | 928h | 928h | GMEC | 49 | Qianghua Zhu, Huawei | zhuqianghua@huawei.com | Rel-18 | 97 |
| 392 | 225.3 | CT3 aspects of GMEC | 257d | 2023-03-13 A | 2024-03-03 A | 100% |  |  | finish no earlier than 2024-03-03 | C3 | 2056h | 2056h | GMEC | 49 | El Moatamid, Abdessamad, Huawei | abdessamad.el.moatamid@huawei.com | Rel-18 | 97 |
| 393 | 225.4 | CT4 aspects of GMEC | 257d | 2023-03-13 A | 2024-03-03 A | 100% |  |  | finish no earlier than 2024-03-03 | C4 | 2056h | 2056h | GMEC | 49 | El Moatamid, Abdessamad, Huawei | abdessamad.el.moatamid@huawei.com | Rel-18 | 97 |
| 394 | 225.5 | CT1 aspects of GMEC | 257d | 2023-03-13 A | 2024-03-03 A | 100% |  |  | finish no earlier than 2024-03-03 | C1 | 2056h | 2056h | GMEC | 49 | El Moatamid, Abdessamad, Huawei | abdessamad.el.moatamid@huawei.com | Rel-18 | 97 |
| 395 | 226 | Application layer support for Factories of the Future (FF) | 387d | 2021-09-10 A | 2023-03-03 A | 100% |  |  | finish no earlier than 2023-03-03 | S6 | 3096h | 3096h | FFAPP | 47 | Shao Weixiang, ZTE Corporation | shao.weixiang@zte.com.cn | Rel-18 | 93 |
| 396 | 227 | **Service Enabler Architecture Layer for Verticals Phase 3** | 458d | 2021-12-10 A | 2023-09-09 | 90% | 43.84d | 649d |  |  | 8319.84h | 4127.84h | SEAL_Ph3 | 48 | Basavaraj (Basu) Pattan, Samsung | basavarajjp@samsung.com | Rel-18 | 94 |
| 397 | 227.1 | Stage 2 of SEAL_Ph3 | 387.98d | 2021-12-12 A | 2023-06-06 A | 100% |  |  | finish no earlier than 2023-06-06 | S6 | 3103.84h | 3103.84h | SEAL_Ph3 | 48 | Basavaraj (Basu) Pattan, Samsung | basavarajjp@samsung.com | Rel-18 | 94 |
| 398 | 227.2 | CT1 aspects of SEAL_Ph3 | 262d | 2021-12-12 A | 2022-12-12 | 65% | 91.7d | 844d | finish no earlier than 2022-12-12 | C1 | 2096h |  | SEAL_Ph3 | 48 | Vijay Sangameshwara (Samsung Electronics) | s.vijay@samsung.com | Rel-18 | 94 |
| 399 | 227.3 | CT3 aspects of SEAL_Ph3 | 262d | 2021-12-10 A | 2022-12-09 | 97% | 7.86d | 845d | finish no earlier than 2022-12-12 | C3 | 2096h |  | SEAL_Ph3 | 48 | Vijay Sangameshwara (Samsung Electronics) | s.vijay@samsung.com | Rel-18 | 94 |
| 400 | 227.4 | Security aspects of SEAL_Ph3 | 128d | 2023-03-16 A | 2023-09-09 A | 100% |  |  | finish no earlier than 2023-09-09 | S3 | 1024h | 1024h | SEAL_Ph3 | 50 | Rajavelsamy Rajadurai, Samsung | rajvel@samsung.com | Rel-18 | 99 |
| 401 | 228 | **SEAL data delivery enabler for vertical applications** | 648d | 2021-09-13 A | 2024-03-03 | 96% | 26.69d | 523d |  |  | 9264h | 6720h | SEALDD | 49 | Niranth Amogh, Huawei Telecommunications India | namogh@huawei.com | Rel-18 | 97 |
| 402 | 228.1 | Study on SEAL data delivery enabler for vertical applications | 261d | 2021-09-13 A | 2022-09-12 A | 100% |  |  | finish no earlier than 2022-09-12 | S6 | 2088h | 2088h | FS_SEALDD | 47 | Niranth Amogh, Huawei Telecommunications India | namogh@huawei.com | Rel-18 | 93 |
| 403 | 228.2 | (Stage 2 of Seal DD) SEAL data delivery enabler for vertical applications | 193d | 2022-09-09 A | 2023-06-06 A | 100% |  |  | finish no earlier than 2023-06-06 | S6 | 1544h | 1544h | SEALDD | 49 | Niranth Amogh, Huawei Telecommunications India | namogh@huawei.com | Rel-18 | 97 |
| 404 | 228.3 | CT1 aspects of SEALDD | 318d | 2022-12-16 A | 2024-03-03 | 85% | 47.7d | 523d | finish no earlier than 2024-03-03 | C1 | 2544h |  | SEALDD | 49 | Herrero Veron, Christian (Huawei) | Christian.Herrero at huawei.com | Rel-18 | 97 |
| 405 | 228.4 | CT3 aspects of SEALDD | 318d | 2022-12-16 A | 2024-03-03 A | 100% |  |  | finish no earlier than 2024-03-03 | C3 | 2544h | 2544h | SEALDD | 49 | Herrero Veron, Christian (Huawei) | Christian.Herrero at huawei.com | Rel-18 | 97 |
| 406 | 228.5 | Security aspects of SEAL Data Delivery enabler | 68d | 2023-06-08 A | 2023-09-09 A | 100% |  |  | finish no earlier than 2023-09-09 | S3 | 544h | 544h | SEALDD | 51 | Ao Lei, Huawei, | leiao@huawei.com | Rel-18 | 100 |
| 407 | 229 | Low Power High Accuracy Positioning for industrial IoT scenarios | 62d | 2021-03-18 A | 2021-06-11 A | 100% |  |  | finish no earlier than 2021-06-12 | S1 | 496h | 496h | LPHAP | 46 | Yuan Wang, Huawei | wangyuan5@huawei.com | Rel-18 | 91 |
| 408 | 230 | Subscriber-aware Northbound API access | 13d | 2020-09-01 A | 2020-09-17 A | 100% |  |  | finish no earlier than 2020-09-17 | S1 | 104h | 104h | SNA | 45 | Minokuchi, Atsushi, NTT DOCOMO | minokuchi at nttdocomo dot com | Rel-18 | 89 |
| 409 | 231 | **Application enablement aspects for subscriber-aware northbound API access** | 333d | 2022-06-02 A | 2023-09-09 A | 100% |  |  |  |  | 4723.6h | 4723.6h | SNAAPP | 49 | Suzuki, Yuji, NTT DOCOMO | yuuji.suzuki.rm@nttdocomo.com | Rel-18 | 96 |
| 410 | 231.1 | Stage 2 of SNAAPP | 196.45d | 2022-06-02 A | 2023-03-03 A | 100% |  |  | finish no earlier than 2023-03-03 | S6 | 1571.6h | 1571.6h | SNAAPP | 49 | Suzuki, Yuji, NTT DOCOMO | yuuji.suzuki.rm@nttdocomo.com | Rel-18 | 96 |
| 411 | 231.2 | Study on SNAAPP securitY | 138d | 2022-06-02 A | 2022-12-12 A | 100% |  |  | finish no earlier than 2022-12-12 | S3 | 1104h | 1104h | FS_SNAAPPY | 49 | Zugenmaier, Alf, NTT DOCOMO, | zugenmai@hm.edu | Rel-18 | 96 |
| 412 | 231.3 | Security aspects of SNAPP | 128d | 2023-03-16 A | 2023-09-09 A | 100% |  |  | finish no earlier than 2023-09-09 | S3 | 1024h | 1024h | SNAAPPY | 50 | Zugenmaier, Alf, NTT DOCOMO | zugenmai@hm.edu | Rel-18 | 99 |
| 413 | 231.4 | CT3 aspects of SNAAPP | 128d | 2023-03-16 A | 2023-09-09 A | 100% |  |  | finish no earlier than 2023-09-09 | C3 | 1024h | 1024h | SNAAPP | 50 | Eitoku, Haruka, NTT | haruka.eitoku@ntt.com | Rel-18 | 99 |

Notes:
- 389: ; 10/12/22: 0%->30; 9/1/23: WID:SP-220989->SP-221339 / Impacted TSs and TRs: 23.501; 23.502; 23.503
- 390: 21/1/22: 23.700-74 added;; 12/3/22: 0%->25; 4/6/22: 25%->70; 12/9/22: 70%->90; 10/12/22: 90%->95; 10/12/22: FCD:12/09/2022->12/22; 15/3/23: 95%->100 / Impacted TSs and TRs: 23.700-74
- 391: ; 10/12/22: 0%->30; 9/1/23: WID:SP-220989->SP-221339; 15/3/23: WID:SP-221339->SP-230101; 15/3/23: 30%->70; 8/6/23: 70%->100 / Impacted TSs and TRs: 23.501; 23.502; 23.503
- 392: 6/6/23: Compl:15%->40%6/6/23: WID: CP-230118->CP-231194 / Impacted TSs and TRs: 29.122.29.512.29.513.29.519.29.522.29.525.29.565.29.502.29.503.29.504.29.505.29.571.24.501.24.526
- 393: 6/6/23: Compl:5%->40%6/6/23: WID: CP-230118->CP-231194 / Impacted TSs and TRs: 29.122.29.512.29.513.29.519.29.522.29.525.29.565.29.502.29.503.29.504.29.505.29.571.24.501.24.526
- 394: 6/6/23: Compl:0%->75%6/6/23: WID: CP-230118->CP-231194 / Impacted TSs and TRs: 29.122.29.512.29.513.29.519.29.522.29.525.29.565.29.502.29.503.29.504.29.505.29.571.24.501.24.526
- 395: Impacted TSs and TRs: 23.434 ; 23.545
- 396: Impacted TSs and TRs: 23.434
- 397: ; 12/3/22: 0%->5; 4/6/22: 5%->20; 12/9/22: 20%->35; 11/12/22: 35%->60. Acronym: eSEAL_Ph2->SEAL_Ph3; 11/12/22: FCD:12/12/2022->/23; 17/3/23: WID:SP-211518->SP-230276; 17/3/23: FCD:03/03/2023->6/6//23; change rapport (was Basavaraj (Basu) Pattan, Samsu...; 8/6/23: 90%->100 / Impacted TSs and TRs: 23.434
- 398: 6/6/23: Compl:10%->45% / Impacted TSs and TRs: 24.544; 24.545; 24.546; 24.547; 24.548; 24.549; 29.549
- 399: 9/6/23: 15%->45 / Impacted TSs and TRs: 24.544; 24.545; 24.546; 24.547; 24.548; 24.549; 29.549
- 400: ; 8/6/23: 0%->80; 15/3/24: 80%->100 / Impacted TSs and TRs: 33.434
- 401: ; 23/9/22: 23.433 added; / Impacted TSs and TRs: 23.434 ; 23.433
- 402: 13/12/21: 0%->30; 12/3/22: 30%->45; 22/3/22: 23.700-34 added;; 4/6/22: 45%->60; 4/6/22: FCD:10/06/2022->09/22; 4/6/22: WID:SP-210955->SP-220467; 12/9/22: 60%->85; 11/12/22: 85%->100 / Impacted TSs and TRs: 23.700-34
- 403: ; 23/9/22: 23.433 added;; 11/12/22: 0%->60; 9/1/23: WID:SP-220914->SP-221232; 17/3/23: 60%->85; 17/3/23: FCD:03/03/2023->/23; 8/6/23: 85%->100 / Impacted TSs and TRs: 23.434 ; 23.433; 23.558
- 404: 30/6/23: WID:CP-230338->CP-231284 / Impacted TSs and TRs: 24.544; 24.545; 24.546; 24.547; 24.548; 24.549; 24.538; 29.549; 29.538; 29.558
- 405: 31/3/23: 29.548 added;; 9/6/23: 5%->25 / Impacted TSs and TRs: 24.544; 24.545; 24.546; 24.547; 24.548; 24.549; 24.538; 29.549; 29.538; 29.558; 29.548
- 406: ; 15/3/24: 0%->100 / Impacted TSs and TRs: 33.434
- 407: ; 19/3/21: 0%->40; 11/6/21: 40%->100 / Impacted TSs and TRs: 22.104; 22.261
- 408: Impacted TSs and TRs: 22.261
- 409: ; 11/12/22: 0%->55 / Impacted TSs and TRs: 23.222; 23.434
- 410: ; 11/12/22: 0%->55; 17/3/23: 15%->90; 8/6/23: 90%->100 / Impacted TSs and TRs: 23.222; 23.434
- 411: 13/7/22: 33.884 added;; 12/9/22: 0%->10; 11/12/22: 10%->50; 17/3/23: 50%->60; 8/6/23: 60%->100 / Impacted TSs and TRs: 33.884
- 412: ; 8/6/23: 0%->50; 8/12/23: 50%->85; 15/3/24: 85%->100 / Impacted TSs and TRs: 33.122
- 413: Impacted TSs and TRs: 29.222

| ID | WBS | Task | Type | Duration | Start | Finish | Complete | Remaining | Total slack | Constraint | Resources | Work | Actual work | Acronym | PCG approved | WI rapporteur name | WI rapporteur e-mail | Release | TSG approved | TSG stopped |
| --- | --- | --- | --- | --- | --- | --- | --- | --- | --- | --- | --- | --- | --- | --- | --- | --- | --- | --- | --- | --- |
| 414 | 232 | **Smart Energy and Infrastructure** |  | 382d | 2020-06-25 A | 2021-12-10 A | 100% |  |  |  |  | 3064h | 3064h | SEI | 47 | XIA Xu, China Telecom | xiaxu@chinatelecom.cn | Rel-18 | 92 |  |
| 415 | 232.1 | Study on 5G Smart Energy and Infrastructure |  | 252d | 2020-06-25 A | 2021-06-11 A | 100% |  |  | finish no earlier than 2021-06-12 | S1 | 2016h | 2016h | FS_5GSEI | 45 | XIA Xu, China Telecom | xiaxu@chinatelecom.cn | Rel-18 | 88 |  |
| 416 | 232.2 | Stage 1 of Smart Energy and Infrastructure |  | 131d | 2021-06-11 A | 2021-12-10 A | 100% |  |  | finish no earlier than 2021-12-12 | S1 | 1048h | 1048h | SEI | 47 | XIA Xu, China Telecom | xiaxu@chinatelecom.cn | Rel-18 | 92 |  |
| 417 | 233 | Study on Network and Service Operations for Energy Utilities |  | 387d | 2021-12-13 A | 2023-06-06 A | 100% |  |  | finish no earlier than 2023-06-06 | S5 | 3096h | 3096h | FS_NSOEU | 48 | Erik Guttman , Samsung | erik.guttman@samsung.com | Rel-18 | 94 |  |
| 418 | 234 | Study on application enablement aspects for subscriber-aware northbound API access |  | 261d | 2021-06-11 A | 2022-06-10 A | 100% |  |  | finish no earlier than 2022-06-12 | S6 | 2088h | 2088h | FS_SNAAPP | 47 | Suzuki, Yuji, NTT DOCOMO | yuuji.suzuki.rm@nttdocomo.com | Rel-18 | 92 |  |
| 419 | 235 | **Rel-18 Enhancements of 3GPP Northbound and Application Layer interfaces and APIs** |  | 458d | 2022-06-03 A | 2024-03-03 A | 100% |  |  |  |  | 7320h | 7320h | NBI18 | 49 | Abdessamad El Moatamid, Huawei | abdessamad.el.moatamid@huawei.com | Rel-18 | 96 |  |
| 420 | 235.1 | CT1 aspects of NBI18 |  | 457d | 2022-06-06 A | 2024-03-03 A | 100% |  |  | finish no earlier than 2024-03-03 | C1 | 3656h | 3656h | NBI18 | 49 | Abdessamad El Moatamid, Huawei | abdessamad.el.moatamid@huawei.com | Rel-18 | 96 |  |
| 421 | 235.2 | CT3 aspects of NBI18 |  | 458d | 2022-06-03 A | 2024-03-03 A | 100% |  |  | finish no earlier than 2024-03-03 | C3 | 3664h | 3664h | NBI18 | 49 | Abdessamad El Moatamid, Huawei | abdessamad.el.moatamid@huawei.com | Rel-18 | 96 |  |
| 422 | 236 | Study on Structure of Charging for Verticals |  | 264d | 2022-12-09 A | 2023-12-12 A | 100% |  |  | finish no earlier than 2023-12-12 | S5 | 2112h | 2112h | FS_SCV | 50 | CHEN SHAN, Huawei | chenshan@huawei.com | Rel-18 | 98 |  |
| 423 | 237 | Charging Aspects of B2B |  | 130d | 2023-09-06 A | 2024-03-03 A | 100% |  |  | finish no earlier than 2024-03-03 | S5 | 1040h | 1040h | B2B_CH | 51 | Deng, Yimeng, Huawei | dengyimeng at huawei dot com | Rel-18 | 101 |  |
| 424 | 238 | Rel-18 Mission Critical and emergencies | milestone | 0d? | 2016-03-15 A | 2016-03-15 A | 100% |  |  | start no earlier than 2016-03-15 |  |  |  |  |  |  |  | Rel-18 |  |  |
| 425 | 239 | SMS over IMS to emergency centre |  | 7d | 2022-06-02 A | 2022-06-10 A | 100% |  |  | finish no earlier than 2022-06-12 | S1 | 56h | 56h | SMS2EC | 49 | Bruno Tossou, Orange | bruno.tossou@orange.com | Rel-18 | 96 |  |
| 426 | 240 | Mission critical security enhancements phase 3 |  | 322d | 2021-12-10 A | 2023-03-03 A | 100% |  |  | finish no earlier than 2023-03-03 | S3 | 2576h | 2576h | MCXSec3 | 48 | Woodward, Tim, Motorola Solutions, Inc. | tim.woodward@motorolasolutions.com | Rel-18 | 94 |  |
| 427 | 241 | **Enhanced Mission Critical Push-to-talk architecture phase 4** |  | 584d | 2021-12-10 A | 2024-03-03 | 96% | 22.03d | 523d |  |  | 4136h | 2576h | enh4MCPTT | 48 | Lazara, Dom, Motorola Solutions | Dom.Lazara@motorolasolutions.com | Rel-18 | 94 |  |
| 428 | 241.1 | Stage 2 of enh4MCPTT |  | 322d | 2021-12-10 A | 2023-03-03 A | 100% |  |  | finish no earlier than 2023-03-03 | S6 | 2576h | 2576h | enh4MCPTT | 48 | Lazara, Dom, Motorola Solutions | Dom.Lazara@motorolasolutions.com | Rel-18 | 94 |  |
| 429 | 241.2 | CT aspects of enh4MCPTT |  | 195d | 2023-06-07 A | 2024-03-03 | 90% | 19.5d | 523d | finish no earlier than 2024-03-03 | C1 | 1560h |  | enh4MCPTT | 51 | Kiran Kapale, Samsung, | kiran.kapale@samsung.com | Rel-18 | 100 |  |
| 430 | 242 | **Gateway UE function for Mission Critical Communication** |  | 965d | 2020-06-25 A | 2024-03-03 | 83% | 159.38d | 523d |  |  | 6200h | 4152h | MCGWUE | 47 | Oettl, Martin, Nokia | martin.oettl@nokia.com | Rel-18 | 93 |  |
| 431 | 242.1 | Study of Gateway UE function for Mission Critical Communication |  | 323d | 2020-06-25 A | 2021-09-20 A | 100% |  |  | finish no earlier than 2021-09-20 | S6 | 2584h | 2584h | FS_MCGWUE | 45 | Oettl, Martin, Nokia | martin.oettl@nokia.com | Rel-18 | 88 |  |
| 432 | 242.2 | (Stage 2 of) Gateway UE function for Mission Critical Communication |  | 196d | 2021-09-10 A | 2022-06-10 A | 100% |  |  | finish no earlier than 2022-06-12 | S6 | 1568h | 1568h | MCGWUE | 47 | Oettl, Martin, Nokia | martin.oettl@nokia.com | Rel-18 | 93 |  |
| 433 | 242.3 | CT1 aspects of MCGWUE |  | 256d | 2023-03-13 A | 2024-03-03 | 50% | 128d | 523d | finish no earlier than 2024-03-03 | C1 | 2048h |  | MCGWUE | 47 | Magnus Tränk, Ericsson | magnus.trank@ericsson.com | Rel-18 | 93 |  |
| 434 | 243 | **Mission Critical Services over 5MBS** |  | 1246d | 2019-03-07 A | 2023-12-12 A | 100% |  |  |  |  | 8912h | 8912h | MCOver5MBS | 47 | Wendler, Ingo, UIC | ingo.wendler@sbb.ch | Rel-18 | 93 |  |
| 435 | 243.1 | Stage 2 of Mission Critical Services over 5MBS |  | 788d | 2019-03-07 A | 2022-03-11 A | 100% |  |  | finish no earlier than 2022-03-12 | S6 | 6296h | 6296h | MCOver5MBS | 47 | Wendler, Ingo, UIC | ingo.wendler@sbb.ch | Rel-18 | 93 |  |
| 436 | 243.2 | CT1 aspects of Mission Critical Services over 5MBS |  | 327d | 2022-09-13 A | 2023-12-12 A | 100% |  |  | finish no earlier than 2023-12-12 | C1 | 2616h | 2616h | MCOver5MBS | 49 | Chen, Ying, TD Tech Ltd. | chenying@td-tech.com | Rel-18 | 97 |  |
| 437 | 244 | **Mission Critical Services over 5GProSe** |  | 1246d | 2019-03-07 A | 2023-12-12 A | 100% |  |  |  |  | 9960h | 9960h | MCOver5GProSe | 48 | Yanmei YANG, Huawei | yangyanmei@huawei.com | Rel-18 | 94 |  |
| 438 | 244.1 | Stage 2 of Mission Critical Services over 5GProSe |  | 919d | 2019-03-07 A | 2022-09-12 A | 100% |  |  | finish no earlier than 2022-09-12 | S6 | 7344h | 7344h | MCOver5GProSe | 48 | Yanmei YANG, Huawei | yangyanmei@huawei.com | Rel-18 | 94 |  |
| 439 | 244.2 | CT1 aspects of Mission Critical Services over 5GProSe |  | 327d | 2022-09-13 A | 2023-12-12 A | 100% |  |  | finish no earlier than 2023-12-12 | C1 | 2616h | 2616h | MCOver5GProSe | 49 | Mengdi Ji, Huawei | jimengdi@huawei.com, | Rel-18 | 97 |  |
| 440 | 245 | Stopped - ProSe Secondary Authentication |  | 125d | 2022-09-12 A | 2023-03-03 A | 100% |  |  | finish no earlier than 2023-03-03 | S3 | 1000h | 1000h | PROSESA | 49 | Samir Ferdi , Interdigital | samir. ferdi @ interdigital . com | Rel-18 | 97 | 101 |
| 441 | 246 | Sharing administrative configuration between interconnected MCX Service systems |  | 66d | 2021-09-10 A | 2021-12-10 A | 100% |  |  | finish no earlier than 2021-12-12 | S1 | 528h | 528h | SACI_MCS | 47 | Toobe, Jens, BDBOS | jens.toobe@bdbos.bmi.bund.de | Rel-18 | 93 |  |
| 442 | 247 | Ad hoc Group Communication support in Mission Critical Services |  | 7d | 2021-09-10 A | 2021-09-20 A | 100% |  |  | finish no earlier than 2021-09-20 | S1 | 56h | 56h | AHGC | 47 | Erik.Guttman, Samsung | Erik.Guttman@samsung.com | Rel-18 | 93 |  |

Notes:
- 414: Impacted TSs and TRs: 22.104;22.261
- 415: 28/7/20: 22.867 added;; 12/9/20: 0%->20; 5/12/20: 20%->60; 19/3/21: FCD:17/03/2021->06/21; 19/3/21: 60%->75; 11/6/21: 75%->90; 13/9/21: 90%->100 / Impacted TSs and TRs: 22.867
- 416: ; 13/9/21: 0%->95; 10/12/21: 95%->100 / Impacted TSs and TRs: 22.104;22.261
- 417: 7/1/22: 28.902 added;; 4/6/22: 0%->25; 12/9/22: 25%->45; 12/9/22: FCD:12/12/2022->03/23; 11/12/22: 45%->55; 11/12/22: FCD:10/03/2023->/23; 17/3/23: 55%->79; 8/6/23: 79%->100 / Impacted TSs and TRs: 28.902
- 418: 2/7/21: 23.700-95 added;; 13/9/21: 0%->20; 13/12/21: 20%->65; 12/3/22: 65%->75; 12/3/22: FCD:11/03/2022->6/22; 12/3/22: WID:SP-210476->SP-220094; 4/6/22: 75%->85; 12/9/22: 85%->90; 11/12/22: 90%->100 / Impacted TSs and TRs: 23.700-95
- 419: 30/6/23: WID:CP-221105->CP-231190
- 420: 6/6/23: Compl:25%->40%6/6/23: WID: CP-221105->CP-231190; 9/6/23: 40%->45; 9/6/23: 45%-> / Impacted TSs and TRs: 24.558
- 421: 6/6/23: Compl:30%->60%6/6/23: WID: CP-221105->CP-231190 / Impacted TSs and TRs: 29.116; 29.122; 29.222; 29.255; 29.257; 29.343; 29.486; 29.522; 29.538; 29.549; 29.558
- 422: 16/3/23: WID:SP-221161->SP-230178; 17/3/23: 0%->8; 17/3/23: 28.843 added;; 8/6/23: 8%->80; 8/6/23: FCD:06/06/2023->12/23; 7/9/23: 80%->100 / Impacted TSs and TRs: 28.843
- 423: ; 8/12/23: 0%->80; 14/3/24: 80%->100 / Impacted TSs and TRs: 32.240; 32.290
- 424: -
- 425: ; 4/6/22: 0%->45; 12/9/22: 45%->100 / Impacted TSs and TRs: 22.101
- 426: ; 4/6/22: 0%->10; 12/9/22: 10%->15; 11/12/22: 15%->35; 17/3/23: 35%->75; 8/6/23: 75%->100 / Impacted TSs and TRs: 33.180
- 427: ; 12/3/22: 0%->10; 4/6/22: 10%->30; 12/9/22: 30%->55; 11/12/22: 55%->65; 17/3/23: 65%->80 / Impacted TSs and TRs: 23.379; 23.280; 23.281; 23.282; 23.283
- 428: ; 12/3/22: 0%->10; 4/6/22: 10%->30; 12/9/22: 30%->55; 11/12/22: 55%->65; 17/3/23: 65%->80; 8/6/23: 80%->100 / Impacted TSs and TRs: 23.379; 23.280; 23.281; 23.282; 23.283
- 429: ; 30/6/23: 24.283 added; / Impacted TSs and TRs: 24.281; 24.282; 24.379; 24.380; 24.481; 24.482; 24.483; 24.484; 24.581; 24.582; 29.379; 29.380; 29.582 ; 24.283
- 430: Impacted TSs and TRs: 23.280; 23.289; 23.281; 23.282; 23.379
- 431: 13/9/20: 0%->10; 25/9/20: 23.700-79 added;; 5/12/20: 10%->30; 21/3/21: 30%->40; 11/6/21: 40%->60; 13/9/21: 60%->100 / Impacted TSs and TRs: 23.700-79
- 432: ; 13/12/21: 0%->50; 12/3/22: 50%->75; 4/6/22: 75%->90; 12/9/22: 90%->100 / Impacted TSs and TRs: 23.280; 23.289; 23.281; 23.282; 23.379
- 433: Impacted TSs and TRs: 24.281.24.282.24.379.24.380.24.483.24.484.24.581.24.582
- 434: ; 13/12/21: 0%->30; 12/3/22: 30%->50; 12/3/22: FCD:11/03/2022->9/22; 4/6/22: 50%->85 / Impacted TSs and TRs: 23.289
- 435: ; 13/12/21: 0%->30; 12/3/22: 30%->50; 12/3/22: FCD:11/03/2022->9/22; 4/6/22: 50%->85; 12/9/22: 0%->98; 12/9/22: FCD:10/06/2020->03/22; 11/12/22: 98%->100 / Impacted TSs and TRs: 23.289
- 436: 6/6/23: Compl:20%->40% / Impacted TSs and TRs: 24.281; 24.282; 24.379; 24.380; 24.481; 24.483; 24.484; 42.581; 24.582
- 437: ; 12/3/22: 0%->50; 4/6/22: 50%->87 / Impacted TSs and TRs: 23.289
- 438: ; 12/3/22: 0%->50; 4/6/22: 50%->87; 12/9/22: 0%->100; 12/9/22: FCD:10/06/2020->09/22 / Impacted TSs and TRs: 23.289
- 439: 3/24: rapporteur changed (was weihaitao@huawei.com) / Impacted TSs and TRs: 24.281; 24.282; 24.379; 24.380; 24.481; 24.483; 24.484; 24.581; 24.582
- 440: ; 17/3/23: 0%->30; 8/6/23: 30%->90. 9/23: stopped at 90% / Impacted TSs and TRs: 33.503
- 441: ; 13/9/21: 0%->80; 10/12/21: 80%->100 / Impacted TSs and TRs: 22.280
- 442: ; 10/12/21: 0%->100 / Impacted TSs and TRs: 22.280

| ID | WBS | Task | Type | Duration | Start | Finish | Complete | Remaining | Total slack | Constraint | Resources | Work | Actual work | Acronym | PCG approved | Release | TSG approved | Status Report |
| --- | --- | --- | --- | --- | --- | --- | --- | --- | --- | --- | --- | --- | --- | --- | --- | --- | --- | --- |
| 443 | 248 | **Mission Critical ad hoc group Communications** |  | 324d | 2022-12-09 A | 2024-03-04 | 93% | 24.29d | 522d |  | S6 | 4640h | 2048h | MC_AHGC | 50 | Rel-18 | 98 |  |
| 444 | 248.1 | Stage 2 of Mission Critical ad hoc group Communications |  | 128d | 2022-12-09 A | 2023-06-06 A | 100% |  |  | finish no earlier than 2023-06-06 | S6 | 1024h | 1024h | MC_AHGC | 50 | Rel-18 | 98 |  |
| 445 | 248.2 | CT1 aspects of Mission Critical ad hoc group Communications |  | 128d | 2023-09-09 A | 2024-03-04 | 85% | 19.2d | 522d | start no earlier than 2023-09-09 | C1 | 1024h |  | MC_AHGC | 50 | Rel-18 | 98 |  |
| 446 | 249 | Study on sharing administrative configuration between interconnected MCX Service systems |  | 582d | 2019-09-19 A | 2021-12-10 A | 100% |  |  | finish no earlier than 2021-12-12 | S1 | 4656h | 4656h | FS_SACI_MCS | 43 | Rel-18 | 85 |  |
| 447 | 250 | Study on sharing of administrative configuration between interconnected MC service systems |  | 320d | 2021-12-13 A | 2023-03-03 A | 100% |  |  | finish no earlier than 2023-03-03 | S6 | 2560h | 2560h | FS_MCShAC | 48 | Rel-18 | 94 |  |
| 448 | 251 | Study on Mission Critical ad hoc group communications |  | 261d | 2021-12-13 A | 2022-12-12 A | 100% |  |  | finish no earlier than 2022-12-12 | S6 | 2088h | 2088h | FS_MCAHGC | 48 | Rel-18 | 94 |  |
| 449 | 252 | Study on Mission Critical services support over 5G System |  | 1048d? | 2018-06-06 A | 2022-06-10 A | 100% |  |  | finish no earlier than 2022-06-12 | S6 | 8384h | 8384h | FS_MCOver5GS | 41 | Rel-18 | 80 |  |
| 450 | 253 | Rel-18 Artificial Intelligence (AI)/Machine Learning (ML) | milestone | 0d? | 2016-03-15 A | 2016-03-15 A | 100% |  |  | start no earlier than 2016-03-15 |  |  |  |  |  | Rel-18 |  |  |
| 451 | 254 | **AI/ML model transfer in 5GS** |  | 526d | 2019-12-06 A | 2021-12-10 A | 100% |  |  |  |  | 4216h | 4216h | AIML_MT | 47 | Rel-18 | 92 |  |
| 452 | 254.1 | Study on traffic characteristics and performance requirements for AI/ML model transfer in 5GS |  | 396d | 2019-12-06 A | 2021-06-11 A | 100% |  |  | finish no earlier than 2021-06-12 | S1 | 3168h | 3168h | FS_AIML_MT | 44 | Rel-18 | 86 |  |
| 453 | 254.2 | Stage 1 of AMMT |  | 131d | 2021-06-11 A | 2021-12-10 A | 100% |  |  | finish no earlier than 2021-12-12 | S1 | 1048h | 1048h | AIML_MT | 47 | Rel-18 | 92 |  |
| 454 | 255 | Study on Artificial Intelligence (AI)/Machine Learning (ML) for NR air interface |  | 523d | 2021-12-13 A | 2023-12-12 A | 100% |  |  | finish no earlier than 2023-12-12 | R1 | 4184h | 4184h | FS_NR_AIML_air | 48 | Rel-18 | 94 | RP-233132 |
| 455 | 256 | **Artificial Intelligence (AI)/Machine Learning (ML)** |  | 577d | 2021-12-20 A | 2024-03-03 | 99% | 4.11d | 523d |  |  | 8656h | 6626.4h | AIMLsys | 50 | Rel-18 | 98 |  |
| 456 | 256.1 | Study on Security and Privacy of AI/ML-based Services and Applications in 5G |  | 184d | 2022-06-21 A | 2023-03-03 A | 100% |  |  | finish no earlier than 2023-03-03 | S3 | 1472h | 1472h | FS_AIML | 49 | Rel-18 | 96 |  |
| 457 | 256.2 | Study on 5G System Support for AI/ML-based Services |  | 256d | 2021-12-20 A | 2022-12-12 A | 100% |  |  | finish no earlier than 2022-12-12 | S2 | 2048h | 2048h | FS_AIMLsys | 48 | Rel-18 | 94 |  |
| 458 | 256.3 | (Stage 2 for AIML) System Support for AI/ML-based Services |  | 128d | 2022-12-09 A | 2023-06-06 A | 100% |  |  | finish no earlier than 2023-06-06 | S2 | 1024h | 1024h | AIMLsys | 50 | Rel-18 | 98 |  |
| 459 | 256.4 | CT3 aspects of AIML |  | 257d | 2023-03-13 A | 2024-03-03 | 97% | 7.71d | 523d | finish no earlier than 2024-03-03 | C3 | 2056h | 26.4h | AIMLsys | 50 | Rel-18 | 99 |  |
| 460 | 256.5 | CT4 aspects of AIML |  | 257d | 2023-03-13 A | 2024-03-03 A | 100% |  |  | finish no earlier than 2024-03-03 | C4 | 2056h | 2056h | AIMLsys | 50 | Rel-18 | 99 |  |
| 461 | 257 | **Artificial Intelligence (AI)/Machine Learning (ML) for NG-RAN** |  | 523d | 2021-12-13 A | 2023-12-12 | 80% | 104.59d | 582d |  |  | 4184h |  | NR_AIML_NGRAN | 48 | Rel-18 | 94 |  |
| 462 | 257.1 | Core part: Artificial Intelligence (AI)/Machine Learning (ML) for NG-RAN |  | 523d | 2021-12-13 A | 2023-12-12 | 80% | 104.6d | 582d | finish no earlier than 2023-12-12 | R3 | 4184h |  | NR_AIML_NGRAN-Core | 48 | Rel-18 | 94 | RP-232673 |
| 463 | 258 | Study on the security aspects of Artificial Intelligence (AI)/Machine Learning (ML) for the NG-RAN |  | 197d | 2022-06-02 A | 2023-03-03 A | 100% |  |  | finish no earlier than 2023-03-03 | S3 | 1576h | 1576h | FS_NR_AIML_NGRAN_SEC | 49 | Rel-18 | 96 |  |
| 464 | 259 | Study on AI/ML management |  | 387d | 2021-12-13 A | 2023-06-06 A | 100% |  |  | finish no earlier than 2023-06-06 | S5 | 3096h | 3096h | FS_AIML_MGMT | 48 | Rel-18 | 94 |  |
| 465 | 260 | AI/ML management |  | 253d | 2023-03-17 A | 2024-03-03 A | 100% |  |  | finish no earlier than 2024-03-03 | S5 | 2024h | 2024h | AIML_MGT | 50 | Rel-18 | 99 |  |
| 466 | 261 | NEF Charging enhancement to support AI/ML in 5GS |  | 4d | 2023-12-07 A | 2023-12-12 A | 100% |  |  | finish no earlier than 2023-12-12 | S5 | 32h | 32h | AIMLsysNEF_CH | 52 | Rel-18 | 102 |  |
| 467 | 262 | Study on Artificial Intelligence (AI) and Machine Learning (ML) for Media |  | 654d | 2022-03-12 A | 2024-09-09 | 60% | 261.6d | 386d | finish no earlier than 2024-09-09 | S4 | 5232h |  | FS_AI4Media | 48 | Rel-19 | 95 |  |
| 468 | 263 | Rel-18 Multicast and Broadcast Services (MBS) | milestone | 0d? | 2016-03-15 A | 2016-03-15 A | 100% |  |  | start no earlier than 2016-03-15 |  |  |  |  |  | Rel-18 |  |  |

Notes:
- 443: ; 11/12/22: 0%->35; 17/3/23: FCD:03/03/2023->/23; 17/3/23: 35%->85; 8/6/23: 85%->100 / Impacted TSs and TRs: 23.280; 23.379; 23.281; 23.282 / WI rapporteur name: Kiran Gurudev Kapale, Samsung / WI rapporteur e-mail: kiran.kapale@samsung.com
- 444: ; 11/12/22: 0%->35; 17/3/23: FCD:03/03/2023->/23; 17/3/23: 35%->85; 8/6/23: 85%->100 / Impacted TSs and TRs: 23.280; 23.379; 23.281; 23.282 / WI rapporteur name: Kiran Gurudev Kapale, Samsung / WI rapporteur e-mail: kiran.kapale@samsung.com
- 445: Impacted TSs and TRs: 24.379, 24.380, 24.281, 24.581, 24.282, 24.582, 24.481, 24.483, 24.484 / WI rapporteur name: Kiran Gurudev Kapale, Samsung / WI rapporteur e-mail: kiran.kapale@samsung.com
- 446: ; 8/10/19: 22.881 added;; 6/12/19: 0%->5; 12/9/20: 5%->20; 19/3/21: 20%->55; 19/3/21: FCD:12/06/2020->12/21; 11/6/21: 55%->90; 13/9/21: 90%->100 / Impacted TSs and TRs: New ; 22.881 / WI rapporteur name: Toobe, Jens, BDBOS / WI rapporteur e-mail: jens.toobe at bdbos.bmi.bund.de
- 447: 7/1/22: 23.700-38 added;; 12/3/22: 0%->5; 4/6/22: 5%->25; 12/9/22: 25%->25; 11/12/22: 25%->65; 17/3/23: 65%->80; 8/6/23: 80%->100 / Impacted TSs and TRs: 23.700-38 / WI rapporteur name: Azem, Dania, BDBOS / WI rapporteur e-mail: dania.azem@bdbos.bmi.bund.de
- 448: 7/1/22: 23.700-76 added;; 12/3/22: 0%->25; 4/6/22: 25%->75; 12/9/22: 75%->90; 12/9/22: FCD:12/09/2022->12/22; 11/12/22: 90%->95; 17/3/23: 95%->100 / Impacted TSs and TRs: 23.700-76 / WI rapporteur name: Arunprasath Ramamoorthy, Samsung / WI rapporteur e-mail: arun.prasath@samsung.com
- 449: 6/8/18: 23.783 added;¦10/9/18: 0%->5¦7/12/18: 5%->35¦7/12/18: FCD:03/19->09/19¦14/12/18: WID:SP-180383->SP-181136. 03/19: Rel corrected (was shown as Rel-17); 31/5/19: 35%->40; 26/3/20: FCD:12/09/2019->09/20; 26/3/20: 40%->45; Rel-16->17; 03/22:Rel17-> / Impacted TSs and TRs: New; 23.783 / WI rapporteur name: Verweij, Kees, The Police of the Netherlands / WI rapporteur e-mail: kees.verweij@politie.nl
- 450: -
- 451: Impacted TSs and TRs: 22.261 / WI rapporteur name: Jia SHEN, OPPO, sj@oppo.com
- 452: 28/7/20: 33.852 added;; 12/9/20: 0%->40; 5/12/20: 40%->70; 19/3/21: FCD:12/03/2021->06/21; 19/3/21: 70%->75; 11/6/21: 75%->95; 13/9/21: 95%->100. 06/22: FS_AMMT->FS_AIML_MT; 21/6/22: WID:SP-191040->SP-220441 / Impacted TSs and TRs: 22.874 / WI rapporteur name: Jia SHEN, Oppo . / WI rapporteur e-mail: sj@oppo.com
- 453: ; 13/9/21: 0%->80; 11/3/22: 80%->10006/22: AMMT->AIML_MT; 21/6/22: WID:SP-210587->SP-220440 / Impacted TSs and TRs: 22.261 / WI rapporteur name: Jia SHEN, OPPO, sj@oppo.com
- 454: TR 38.8xx; compare REL-18 WI NR_AIML_NGRAN-Core; 21/1/22: 38.843 added;; 22/3/22: Stat Rep: ->RP-220534 ; 6/6/22: Compl:0%->5% 20/6/22: Acronym:FS_NR_AIML_air->FS_NR_AIML_Air; Rapporteur: Qualcomm->Juan Montojo, Qualcomm; Rap eMail: ->juanm@qti....;...; 8/12/23: Compl:80%->100%; Stat Rep: RP-232659->RP-233132; / Impacted TSs and TRs: 38.843 / WI rapporteur name: Juan Montojo (RAN1); Mattias Frenne (RAN2); Xiaofeng Liu (RAN4), Qualcomm; Ericsson; CAICT / WI rapporteur e-mail: juanm@qti.qualcomm.com; mattias.frenne@ericsson.com; liuxiaofeng1@caict.ac.cn
- 455: 10/12/22: 0%->5; 3/1/24: WID:SP-221329->SP-231278 / Impacted TSs and TRs: 23.501; 23.502; 23.503; 23.288 / WI rapporteur name: Alla Goldner, Oppo / WI rapporteur e-mail: v-alla.goldner@oppo.com
- 456: 13/7/22: 33.898 added;; 12/9/22: 0%->5; 11/12/22: 5%->25; 17/3/23: 25%->35; 7/9/23: 35%->100 / Impacted TSs and TRs: 33.898 / WI rapporteur name: Marcus Wong, OPPO / WI rapporteur e-mail: marcus.wong@oppo.com
- 457: 21/1/22: 23.700-80 added;; 12/3/22: 0%->10; 12/3/22: WID:SP-211648->SP-220071; 4/6/22: 10%->60; 12/9/22: 60%->70; 10/12/22: 70%->100; 10/12/22: FCD:12/09/2022->12/22 / Impacted TSs and TRs: 23.700-80 / WI rapporteur name: Alla Goldner, Oppo / WI rapporteur e-mail: v-alla.goldner@oppo.com
- 458: 10/12/22: 0%->5; 15/3/23: WID:SP-221329->SP-230095; 15/3/23: 5%->50; 8/6/23: 50%->100; 3/1/24: WID:SP-230095->SP-231278 / Impacted TSs and TRs: 23.501; 23.502; 23.503; 23.288 / WI rapporteur name: Alla Goldner, Oppo / WI rapporteur e-mail: v-alla.goldner@oppo.com
- 459: 31/3/23: 29.543 added;6/6/23: Compl:10%->50% / Impacted TSs and TRs: 29.122.29.513.29.514.29.517.29.591.29.519.29.520.29.521.29.522.29.244.29.503.29.504.29.505.29.510; 29.543 / WI rapporteur name: Tangudu, Narendranath Durga, Samsung / WI rapporteur e-mail: n.tangudu@samsung.com
- 460: 6/6/23: Compl:0%->60% / Impacted TSs and TRs: 29.122.29.513.29.514.29.517.29.591.29.519.29.520.29.521.29.522.29.244.29.503.29.504.29.505.29.510 / WI rapporteur name: Tangudu, Narendranath Durga, Samsung / WI rapporteur e-mail: n.tangudu@samsung.com
- 461: no Perf. part; compare REL-18 SI FS_NR_AIML_air; 5/4/22: WID:RP-213602->RP-220635; 2/1/24: WID:RP-220635->RP-233441 / WI rapporteur name: CMCC
- 462: no Perf. part; compare REL-18 SI FS_NR_AIML_air; 20/6/22: FCD:23/06/2023->23/06/2022; WID: RP-220635->RP-213602; Stat Rep: ->RP-221381; Rapporteur: CMCC->Fang Xie, Angelo Centonza, CMCC, Ericsson; Rap eMail: ->xiefang@chinamobile.com, angelo.centonza@e...; 21/9/23: Stat Rep: RP-232235->RP-232673; / WI rapporteur name: Fang Xie, Angelo Centonza, CMCC, Ericsson / WI rapporteur e-mail: xiefang@chinamobile.com, angelo.centonza@ericsson.com
- 463: 13/7/22: 33.877 added; 17/8/22: WID in SP-220529 marked as withdrawn in SA#96 tdoc list; 12/9/22: 0%->10; 11/12/22: 10%->30; 17/3/23: 30%->70. 030/6/23: "undeleted" as per Mirko+Vlasios email; 7/9/23: 70%->100 / Impacted TSs and TRs: 33.877 / WI rapporteur name: Tsiatsis, Vlasios, Ericsson / WI rapporteur e-mail: vlasios.tsiatsis@ericsson.com
- 464: 7/1/22: 28.908 added;; 4/6/22: 0%->10; 12/9/22: 10%->55; 12/9/22: FCD:12/09/2022->03/23; 11/12/22: 55%->85; 11/12/22: FCD:10/03/2023->/23; 8/6/23: 85%->; 8/6/23: FCD:03/03/2023->/23; 8/6/23: 85%->100 / Impacted TSs and TRs: 28.908 / WI rapporteur name: Yao, Yizhi, Intel / WI rapporteur e-mail: yizhi<dot>yao<at>intel<dot>com
- 465: ; 8/6/23: 0%->20; 7/9/23: 20%->35; 14/3/24: 35%->100; 14/3/24: FCD:12/12/2023->/24 / Impacted TSs and TRs: 28.105; 28.552; 32.425; 28.554; 28.541 / WI rapporteur name: Yao, Yizhi, Intel / WI rapporteur e-mail: yizhi<dot>yao<at>intel<dot>com
- 466: ; 14/3/24: 0%->100; 14/3/24: 100%->100 / Impacted TSs and TRs: 32.254; 32.291 / WI rapporteur name: Alla Goldner, OPPO / WI rapporteur e-mail: v-alla.goldner@oppo.com
- 467: 5/4/22: 26.927 added;; 4/6/22: 0%->10; 12/9/22: 10%->15; 12/9/22: FCD:12/03/2022->12/23; 11/12/22: 15%->20; 17/3/23: 20%->25; 8/6/23: 25%->35; 8/6/23: FCD:12/12/2023->/24; 7/9/23: 35%->40; 21/9/23: 26.847 added;; 8/12/23: 40%->50; 14/3/24: 50%->60; 14/3/24: FCD:03/03/2024->9/9/24; Rel-18->Rel-19 / Impacted TSs and TRs: 26.927; 26.847 / WI rapporteur name: Eric Yip, Samsung / WI rapporteur e-mail: eric.yip@samsung.com
- 468: -

| ID | WBS | Task | Type | Duration | Start | Finish | Complete | Remaining | Total slack | Constraint | Resources | Work | Actual work | Acronym | PCG approved | WI rapporteur name | Release | TSG approved | WI rapporteur e-mail | Status Report | TSG stopped |
| --- | --- | --- | --- | --- | --- | --- | --- | --- | --- | --- | --- | --- | --- | --- | --- | --- | --- | --- | --- | --- | --- |
| 469 | 264 | **Enhancements of NR Multicast and Broadcast Services** |  | 523d | 2021-12-13 A | 2023-12-12 A | 100% |  |  |  |  | 4184h | 4184h | NR_MBS_enh | 48 | CATT | Rel-18 | 94 |  |  |  |
| 470 | 264.1 | Core part: Enhancements of NR Multicast and Broadcast Services |  | 523d | 2021-12-13 A | 2023-12-12 A | 100% |  |  | finish no earlier than 2023-12-12 | R2 | 4184h | 4184h | NR_MBS_enh-Core | 48 | Rui Zhou, CATT | Rel-18 | 94 | zhourui@catt.cn | RP-232992 |  |
| 471 | 265 | **5G multicast-broadcast services Phase 2** |  | 577d | 2021-12-20 A | 2024-03-03 | 99% | 1.04d | 523d |  |  | 11360h | 9304h | 5MBS_Ph2 | 50 | Meng Li, Huawei, Huawei | Rel-18 | 98 | raymond.limeng@huawei.com |  |  |
| 472 | 265.1 | Study on architectural enhancements for 5G multicast-broadcast services Phase 2 |  | 256d | 2021-12-20 A | 2022-12-12 A | 100% |  |  | finish no earlier than 2022-12-12 | S2 | 2048h | 2048h | FS_5MBS_Ph2 | 48 | Meng Li, Huawei | Rel-18 | 94 | raymond.limeng@huawei.com |  |  |
| 473 | 265.2 | (Stage 2 of 5MBS_Ph2) Architectural enhancements for 5G multicast-broadcast services Phase 2 |  | 128d | 2022-12-09 A | 2023-06-06 A | 100% |  |  | finish no earlier than 2023-06-06 | S2 | 1024h | 1024h | 5MBS_Ph2 | 50 | Meng Li, Huawei, Huawei | Rel-18 | 98 | raymond.limeng@huawei.com |  |  |
| 474 | 265.3 | CT1 aspects for 5MBS_Ph2 |  | 257d | 2023-03-13 A | 2024-03-03 A | 100% |  |  | finish no earlier than 2024-03-03 | C1 | 2056h | 2056h | 5MBS_Ph2 | 50 | Rezagah, Roya, Huawei | Rel-18 | 99 | roya.rezagah@huawei.com |  |  |
| 475 | 265.4 | CT3 aspects for 5MBS_Ph2 |  | 257d | 2023-03-13 A | 2024-03-03 | 99% | 2.57d | 523d | finish no earlier than 2024-03-03 | C3 | 2056h |  | 5MBS_Ph2 | 50 | Rezagah, Roya, Huawei | Rel-18 | 99 | roya.rezagah@huawei.com |  |  |
| 476 | 265.5 | CT4 aspects for 5MBS_Ph2 |  | 257d | 2023-03-13 A | 2024-03-03 A | 100% |  |  | finish no earlier than 2024-03-03 | C4 | 2056h | 2056h | 5MBS_Ph2 | 50 | Rezagah, Roya, Huawei | Rel-18 | 99 | roya.rezagah@huawei.com |  |  |
| 477 | 265.6 | Security Enhancements for 5G Multicast-Broadcast Services Phase 2 |  | 68d | 2023-06-08 A | 2023-09-09 A | 100% |  |  | finish no earlier than 2023-09-09 | S3 | 544h | 544h | 5MBS_Ph2 | 51 | Longhua Guo, Huawei Technologies | Rel-18 | 100 | guolonghua@huawei.com |  |  |
| 478 | 265.7 | Study on security enhancements for 5G multicast-broadcast services Phase 2 |  | 197d | 2022-06-02 A | 2023-03-03 A | 100% |  |  | finish no earlier than 2023-03-03 | S3 | 1576h | 1576h | FS_5MBS_SEC_Ph2 | 49 | Longhua Guo, Huawei Technologies | Rel-18 | 96 | guolonghua@huawei.com |  |  |
| 479 | 266 | **New bands and bandwidth allocation for 5G terrestrial broadcast - part 2** |  | 585d | 2021-06-15 A | 2023-09-08 A | 100% |  |  |  |  | 4680h | 4680h | LTE_terr_bcast_bands_part2 | 47 | EBU | Rel-18 | 92 |  |  |  |
| 480 | 266.1 | Core part: New bands and bandwidth allocation for 5G terrestrial broadcast - part 2 |  | 585d | 2021-06-15 A | 2023-09-08 A | 100% |  |  | finish no earlier than 2023-09-08 | R4 | 4680h | 4680h | LTE_terr_bcast_bands_part2-Core | 47 | Gene Fong, Qualcomm Incorporated | Rel-18 | 92 | gfong@qti.qualcomm.com | RP-235288 |  |
| 481 | 267 | **UE pre-configuration for 5MBS** |  | 257d | 2023-03-13 A | 2024-03-03 A | 100% |  |  |  |  | 2136h | 2136h | UEConfig5MBS | 47 | Herrero-Veron, Christian(Huawei) | Rel-18 | 92 | Christian.Herrero@huawei.com |  |  |
| 482 | 267.1 | CT1 aspects of UEConfig5MBS |  | 257d | 2023-03-13 A | 2024-03-03 A | 100% |  |  | finish no earlier than 2024-03-03 | C1 | 2056h | 2056h | UEConfig5MBS | 47 | Herrero-Veron, Christian(Huawei) | Rel-18 | 92 | Christian.Herrero@huawei.com |  |  |
| 483 | 267.2 | CT6 aspects of UEConfig5MBS |  | 10d | 2023-03-13 A | 2023-03-24 A | 100% |  |  | finish no earlier than 2023-03-24 | C6 | 80h | 80h | UEConfig5MBS | 47 | Herrero-Veron, Christian(Huawei) | Rel-18 | 92 | Christian.Herrero@huawei.com |  |  |
| 484 | 268 | See also MCOver5MBS under Mission Critical | milestone | 0d? | 2016-03-15 A | 2016-03-15 A | 100% |  |  | start no earlier than 2016-03-15 |  |  |  |  |  |  | Rel-18 |  |  |  |  |
| 485 | 269 | See also TEI18_MBS4V2X under Autonomous Driving | milestone | 0d? | 2016-03-15 A | 2016-03-15 A | 100% |  |  | start no earlier than 2016-03-15 |  |  |  |  |  |  | Rel-18 |  |  |  |  |
| 486 | 270 | Rel-18 Slice | milestone | 0d? | 2016-03-15 A | 2016-03-15 A | 100% |  |  | start no earlier than 2016-03-15 |  |  |  |  |  |  | Rel-18 |  |  |  |  |
| 487 | 271 | Study on 5G NR UE full stack testing for Network Slicing |  | 400d | 2021-03-12 A | 2022-09-22 A | 100% |  |  | finish no earlier than 2022-09-22 | R5 | 3200h | 3200h | FS_NR_Slice_Test | 46 | Dan SONG, Yu SHI, CMCC, CU | Rel-18 | 91 | songdan@chinamobile.com, shiyu19@chinaunicom.cn | RP-221363 |  |
| 488 | 272 | Study on network slice management capability exposure |  | 580d | 2021-03-18 A | 2023-06-06 A | 100% |  |  | finish no earlier than 2023-06-06 | S5 | 4640h | 4640h | FS_NSCE | 46 | Xiaobo Yu, Alibaba Group | Rel-18 | 91 | shibo.yxb@alibaba-inc.com |  |  |
| 489 | 273 | **Enhanced Access to and Support of Network Slice** |  | 965d | 2020-06-25 A | 2024-03-03 A | 100% |  |  |  |  | 7216h | 7216h | EASNS | 46 | Chun, SungDuck, LG Electronics Inc. | Rel-18 | 91 | sungduck.chun@lge.com |  |  |
| 490 | 273.1 | Study on EASNS |  | 190d | 2020-06-25 A | 2021-03-17 A | 100% |  |  | finish no earlier than 2021-03-17 | S1 | 1520h | 1520h | FS_EASNS | 45 | Chun, SungDuck, LG Electronics Inc | Rel-18 | 88 | sungduck.chun@lge.com |  |  |
| 491 | 273.2 | Stage 1 for EASNS |  | 127d | 2021-03-18 A | 2021-09-10 A | 100% |  |  | finish no earlier than 2021-09-12 | S1 | 1016h | 1016h | EASNS | 46 | Chun, SungDuck, LG Electronics Inc. | Rel-18 | 91 | sungduck.chun@lge.com |  |  |
| 492 | 273.3 | Stopped – CT1 aspects of Slice-based PLMN Selection |  | 195d | 2023-06-07 A | 2024-03-03 A | 100% |  |  | finish no earlier than 2024-03-03 | C1 | 1560h | 1560h | PLMNsel_NS | 51 | Shuang Liang, ZTE | Rel-18 | 100 | liang.shuang3@zte.com.cn |  | CP-102 |
| 493 | 273.4 | Stopped – CT4 aspects of Slice-based PLMN Selection |  | 195d | 2023-06-07 A | 2024-03-03 A | 100% |  |  | finish no earlier than 2024-03-03 | C4 | 1560h | 1560h | PLMNsel_NS | 51 | Shuang Liang, ZTE | Rel-18 | 100 | liang.shuang3@zte.com.cn |  | CP-102 |
| 494 | 273.5 | Stopped – CT6 aspects of Slice-based PLMN Selection |  | 195d | 2023-06-07 A | 2024-03-03 A | 100% |  |  | finish no earlier than 2024-03-03 | C6 | 1560h | 1560h | PLMNsel_NS | 51 | Shuang Liang, ZTE | Rel-18 | 100 | liang.shuang3@zte.com.cn |  | CP-102 |

Notes:
- 469: no Perf. part; compare REL-17 WI NR_MBS-Core; 12/7/22: WID:RP-213568->RP-221458; 6/10/23: WID:RP-221458->RP-231829; 2/1/24: WID:RP-231829->RP-232993
- 470: no Perf. part; compare REL-17 WI NR_MBS-Core; 22/3/22: Stat Rep: ->RP-220734 ; 6/6/22: CD:12/12/2023->23/12/2022 ; 6/6/22: Stat Rep: RP-220734->RP-221459; 20/6/22: Rapporteur: CATT->Erlin Zeng, CATT; Rap eMail: ->erlin.zeng@catt.cn13/7/22: FCD:23...;...; 8/12/23: Compl:75%->100%; Stat Rep: RP-231830->RP-232992; Rapporteur: Erlin Zeng, CATT->Rui Zhou, CATT; Rap eMail: erlin.zeng@catt.cn->zhourui@catt.cn;
- 471: Impacted TSs and TRs: 23.501; 23.502; 23.247
- 472: 21/1/22: 23.700-47 added;; 12/3/22: 0%->15; 12/3/22: WID:SP-211645->SP-220072; 4/6/22: 15%->55; 12/9/22: 55%->75; 12/9/22: FCD:12/09/2022->12/22; 10/12/22: 75%->100 / Impacted TSs and TRs: 23.700-47
- 473: ; 15/3/23: WID:SP-221131->SP-230099; 15/3/23: 0%->75; 8/6/23: 75%->100 / Impacted TSs and TRs: 23.501; 23.502; 23.247
- 474: 6/6/23: Compl:0%->65%; 30/6/23: WID:CP-230023->CP-231024. 03/24: rapporteur changed (was giorgi.gulbani@huawei.com)
- 475: ; 9/6/23: 15%->40
- 476: ; 17/3/23: 5%->206/6/23: Compl:20%->70%
- 477: ; 15/3/24: 0%->100 / Impacted TSs and TRs: 33.501
- 478: 13/7/22: 33.883 added;; 12/9/22: 0%->12; 11/12/22: 12%->50; 17/3/23: 50%->55; 8/6/23: 55%->100 / Impacted TSs and TRs: 33.883
- 479: RAN4 part for WI LTE_terr_bcast_bands_part1-Core; REL--independent starting from REL-17; no Perf. part ; 5/4/22: WID:RP-211145->RP-220518; 23/9/22: WID:RP-220518->RP-222224; 9/1/23: WID:RP-222224->RP-223378
- 480: RAN4 part for WI LTE_terr_bcast_bands_part1-Core; REL--independent starting from REL-17; no Perf. part ; 13/9/21: CD:Wed 15/03/23->Wed 23/03/22 ; 22/3/22: CD:23/03/2022->12/06/2023; 22/3/22: Stat Rep: RP ; 6/6/22: CD:12/06/2023->23/0 ; 20/6/22: Rappor...; 6/10/23: WID:RP-231216->RP-232590 / Impacted TSs and TRs: 36.792
- 481: Impacted TSs and TRs: 31.102
- 482: 6/6/23: Compl:85%->95%6/6/23: CD:24/03/2023->03/03/2024 / Impacted TSs and TRs: 31.102
- 483: Impacted TSs and TRs: 31.102
- 484: -
- 485: -
- 486: -
- 487: TR 38.9XX; compare RAN2 REL-17 SI FS_NR_slice; related to REL-15 WI 5GS_Ph1 and REL-16 WI eNS) ; 2/7/21: 0%->10; 13/9/21: Compl:10%->28%; ; 29/9/21: WID:RP-210371->RP-211977; 04/22: Rel-17->Rel-18; 20/6/22: FCD:22/03/2022->22/09/2022; Compl:28%->82%; ...; 23/9/22: 100%->100
- 488: ; 11/6/21: 0%->5; 11/6/21: FCD:Fri 10/12/->12/21; 13/9/21: 5%->25; 13/12/21: 25%->65; 13/12/21: FCD:Fri 10/12/->03/22; 12/3/22: Rel-17->Rel-18; 22/3/22: WID:SP-210131->SP-220350; 4/6/22: 65%->80; 4/6/22: FCD:11/03/2022->03/23; 12/9/22: 80%->83; 12/9/2...; 8/6/23: 92%->100 / Impacted TSs and TRs: New
- 489: Impacted TSs and TRs: 22.261
- 490: 12/9/20: 0%->20; 25/9/20: 22.835 added;; 5/12/20: 20%->60; 19/3/21: 60%->85; 11/6/21: 85%->100 / Impacted TSs and TRs: 22.835
- 491: ; 11/6/21: 0%->100 / Impacted TSs and TRs: 22.261
- 492: 8/8/23: acronym changed SbPS to PLMNsel_NS / Impacted TSs and TRs: 23.122; 24.501; 29.503; 29.504; 29.505; 29.509; 29.544; 29.550; 31.102; 31.111
- 493: stopped / Impacted TSs and TRs: 23.122; 24.501; 29.503; 29.504; 29.505; 29.509; 29.544; 29.550; 31.102; 31.111
- 494: stopped / Impacted TSs and TRs: 23.122; 24.501; 29.503; 29.504; 29.505; 29.509; 29.544; 29.550; 31.102; 31.111

| ID | WBS | Task | Type | Duration | Start | Finish | Complete | Remaining | Total slack | Constraint | Resources | Work | Actual work | Acronym | PCG approved | WI rapporteur name | WI rapporteur e-mail | Release | TSG approved | Status Report |
| --- | --- | --- | --- | --- | --- | --- | --- | --- | --- | --- | --- | --- | --- | --- | --- | --- | --- | --- | --- | --- |
| 495 | 274 | **Network Slicing Phase 3** |  | 577d | 2021-12-20 A | 2024-03-03 | 99% | 3.23d | 523d |  |  | 10992h | 6880h | eNS_Ph3 | 50 | ZHU Jinguo, ZTE | zhu.jinguo@zte.com.cn | Rel-18 | 98 |  |
| 496 | 274.1 | Study on Enhancement of Network Slicing Phase 3 |  | 256d | 2021-12-20 A | 2022-12-12 A | 100% |  |  | finish no earlier than 2022-12-12 | S2 | 2048h | 2048h | FS_eNS_Ph3 | 48 | ZHU Jinguo, ZTE | zhu.jinguo@zte.com.cn | Rel-18 | 94 |  |
| 497 | 274.2 | Study on enhanced security for network slicing Phase 3 |  | 197d | 2022-06-02 A | 2023-03-03 A | 100% |  |  | finish no earlier than 2023-03-03 | S3 | 1576h | 1576h | FS_eNS_Ph3 | 49 | Zander Lei, Huawei | lei.zhongding@huawei.com | Rel-18 | 96 |  |
| 498 | 274.3 | Stage 2 of Network Slicing Phase 3 |  | 128d | 2022-12-09 A | 2023-06-06 A | 100% |  |  | finish no earlier than 2023-06-06 | S2 | 1024h | 1024h | eNS_Ph3 | 50 | ZHU Jinguo, ZTE | zhu.jinguo@zte.com.cn | Rel-18 | 98 |  |
| 499 | 274.4 | CT1 aspects of Network Slicing Phase 3 |  | 257d | 2023-03-13 A | 2024-03-03 A | 100% |  |  | finish no earlier than 2024-03-03 | C1 | 2056h | 2056h | eNS_Ph3 | 50 | Hannah Wang, ZTE | wang.menghan@zte.com.cn | Rel-18 | 99 |  |
| 500 | 274.5 | CT3 aspects of Network Slicing Phase 3 |  | 257d | 2023-03-13 A | 2024-03-03 | 98% | 5.14d | 523d | finish no earlier than 2024-03-03 | C3 | 2056h |  | eNS_Ph3 | 50 | Hannah Wang, ZTE | wang.menghan@zte.com.cn | Rel-18 | 99 |  |
| 501 | 274.6 | CT4 aspects of Network Slicing Phase 3 |  | 257d | 2023-03-13 A | 2024-03-03 | 99% | 2.57d | 523d | finish no earlier than 2024-03-03 | C4 | 2056h |  | eNS_Ph3 | 50 | Hannah Wang, ZTE | wang.menghan@zte.com.cn | Rel-18 | 99 |  |
| 502 | 274.7 | Network Slice Replacement charging |  | 22d | 2024-02-02 A | 2024-03-03 A | 100% |  |  | finish no earlier than 2024-03-03 | S5 | 176h | 176h | eNS_Ph3_CH |  | Maryse Gardella, MATRIXX Software, | Maryse dot Gardella at Matrixx dot com) | Rel-18 |  |  |
| 503 | 275 | **Network Slicing Phase 3: NR aspects** |  | 204d | 2023-03-03 A | 2023-12-12 A | 100% |  |  |  | R3 | 3264h | 3264h | eNS_Ph3-NR | 50 | ZTE |  | Rel-18 | 99 |  |
| 504 | 275.1 | Core part: Network Slicing Phase 3: NR aspects |  | 204d | 2023-03-03 A | 2023-12-12 A | 100% |  |  | finish no earlier than 2023-12-12 | R3 | 1632h | 1632h | eNS_Ph3-NR-Core | 50 | Dapeng Li, ZTE | Li.dapeng@zte.com.cn | Rel-18 | 99 | RP-232866 |
| 505 | 276 | Network slicing provisioning rules |  | 525d | 2021-12-10 A | 2023-12-12 A | 100% |  |  | finish no earlier than 2023-12-12 | S5 | 4200h | 4200h | NSRULE | 48 | Robert Petersen, Ericsson | robert.petersen@ericsson.com | Rel-18 | 94 |  |
| 506 | 277 | Study on intent-driven management for network slicing |  | 460d | 2022-03-10 A | 2023-12-12 A | 100% |  |  | finish no earlier than 2023-12-12 | S5 | 3680h | 3680h | FS_NETSLICE_IDMS | 48 | Jan Groenendijk , Ericsson | Jan.Groenendijk@ericsson.com | Rel-18 | 95 |  |
| 507 | 278 | Intent driven Management Service for Mobile Network phase 2 |  | 195d | 2023-03-16 A | 2023-12-12 A | 100% |  |  | finish no earlier than 2023-12-12 | S5 | 1560h | 1560h | IDMS_MN_ph2 | 50 | Xu Ruiyue, Huawei | Xuruiyue@huawei.com | Rel-18 | 99 |  |
| 508 | 279 | Study on enhanced security for network slicing Phase 2 |  | 192d | 2021-03-18 A | 2021-12-10 A | 100% |  |  | finish no earlier than 2021-12-12 | S3 | 1536h | 1536h | FS_eNS2_SEC | 46 | Zander Lei, Huawei | lei.zhongding@huawei.com | Rel-18 | 91 |  |
| 509 | 280 | Study on Media Streaming aspects of Network Slicing Phase 2 |  | 391d | 2022-06-15 A | 2023-12-12 A | 100% |  |  | finish no earlier than 2023-12-12 | S4 | 3128h | 3128h | FS_MS_NS_Ph2 | 49 | Prakash Kolan, samsung | p.kolan@samsung.com | Rel-18 | 96 |  |
| 510 | 281 | Enhanced security for Phase 2 network slicing |  | 66d | 2021-12-10 A | 2022-03-11 A | 100% |  |  | finish no earlier than 2022-03-11 | S3 | 528h | 528h | eNS2_SEC | 48 | Lei, Zander, Huawei | lei.zhongding@huawei.com | Rel-18 | 94 |  |
| 511 | 282 | Study on Network Slice Capability Exposure for Application Layer Enablement |  | 388d | 2021-03-18 A | 2022-09-12 A | 100% |  |  | finish no earlier than 2022-09-12 | S6 | 3104h | 3104h | FS_NSCALE | 46 | Zheng, Shaowen, CMCC | zhengshaowen@chinamobile.com | Rel-18 | 91 |  |
| 512 | 283 | **Network Slice Capability Exposure for Application Layer Enablement** |  | 470d | 2022-06-02 A | 2024-03-15 | 91% | 41.23d | 512d |  |  | 12832h | 6904h | NSCALE | 49 | Zheng, Shaowen, CMCC | zhengshaowen@chinamobile.com | Rel-18 | 96 |  |
| 513 | 283.1 | (Stage 2 of NSCALE) Network Slice Capability Exposure for Application Layer Enablement |  | 197d | 2022-06-02 A | 2023-03-03 A | 100% |  |  | finish no earlier than 2023-03-03 | S6 | 1576h | 1576h | NSCALE | 49 | Zheng, Shaowen, CMCC | zhengshaowen@chinamobile.com | Rel-18 | 96 |  |
| 514 | 283.2 | CT1 aspects of NSCALE |  | 469d | 2022-06-02 A | 2024-03-14 | 80% | 93.8d | 513d | finish no earlier than 2024-03-15 | C1 | 3752h |  | NSCALE | 49 | Huang Zhenning, China Mobile | huangzhenning@chinamobile.com | Rel-18 | 96 |  |
| 515 | 283.3 | CT3 aspects of NSCALE |  | 469d | 2022-06-02 A | 2024-03-14 | 90% | 46.9d | 513d | finish no earlier than 2024-03-15 | C3 | 3752h | 1576h | NSCALE | 49 | Huang Zhenning, China Mobile | huangzhenning@chinamobile.com | Rel-18 | 96 |  |
| 516 | 283.4 | CT4 aspects of NSCALE |  | 469d | 2022-06-02 A | 2024-03-15 A | 100% |  |  | finish no earlier than 2024-03-15 | C4 | 3752h | 3752h | NSCALE | 49 | Huang Zhenning, China Mobile | huangzhenning@chinamobile.com | Rel-18 | 96 |  |
| 517 | 284 | Study on new UICC application for network slice-specific authentication and authorization (NSSAA) |  | 332d | 2022-06-03 A | 2023-09-09 A | 100% |  |  | finish no earlier than 2023-09-09 | C6 | 2656h | 2656h | FS_NS_Slice-USIM | 49 | COLLET, Hervé, Thales | herve.collet@thalesgroup.com | Rel-18 | 96 |  |
| 518 | 285 | Study on Charging Aspects for Network Slicing Phase 2 |  | 559d | 2021-01-12 A | 2023-03-03 A | 100% |  |  | finish no earlier than 2023-03-03 | S5 | 4472h | 4472h | FS_NETSLICE_CH_Ph2 | 46 | Matrixx, Gerald Görmer | Gerald dot Goermer at Matrixx dot com | Rel-18 | 90 |  |
| 519 | 286 | Charging Aspects of Network Slicing Phase 2 |  | 322d | 2022-12-12 A | 2024-03-03 A | 100% |  |  | finish no earlier than 2024-03-03 | S5 | 2576h | 2576h | NETSLICE_CH_Ph2 | 50 | Gerald Görmer, MATRIXX Software | Gerald dot Goermer at Matrixx dot com | Rel-18 | 98 |  |
| 520 | 287 | Enhancement of Network Slicing UICC application for network slice-specific authentication and authorization |  | 178d | 2023-06-30 A | 2024-03-03 A | 100% |  |  | finish no earlier than 2024-03-03 | C6 | 1424h | 1424h | eNS_UICC | 51 | COLLET, Hervé, Thales | herve.collet@thalesgroup.com | Rel-18 | 100 |  |
| 521 | 288 | Rel-18 eXtended, Augmented and Virtual Reality (XR, AR, VR), immersive | milestone | 0d? | 2019-03-07 | 2019-03-07 |  |  | 1828d |  |  |  |  |  |  |  |  | Rel-18 |  |  |

Notes:
- 495: Impacted TSs and TRs: 23.501; 23.502; 23.503
- 496: 21/1/22: 23.700-41 added;; 21/1/22: 23.700-17 added;; 12/3/22: 0%->5; 12/3/22: WID:SP-211641->SP-220073; 4/6/22: 5%->50; 12/9/22: 50%->70; 12/9/22: FCD:12/09/2022->12/22; 10/12/22: 70%->100 / Impacted TSs and TRs: 23.700-41; 23.700-17
- 497: 13/7/22: 33.886 added;; 11/12/22: 0%->15; 17/3/23: 15%->50; 8/6/23: 50%->90; 15/3/24: 90%->100 / Impacted TSs and TRs: 33.886
- 498: ; 15/3/23: WID:SP-221327->SP-230104; 15/3/23: 0%->50; 8/6/23: 50%->100 / Impacted TSs and TRs: 23.501; 23.502; 23.503
- 499: 6/6/23: Compl:0%->40% / Impacted TSs and TRs: 24.501.29.244.29.502.29.503.29.510.29.531.29.536.29.507.29.512.29.513.29.519.29.522
- 500: ; 9/6/23: 0%->30 / Impacted TSs and TRs: 24.501.29.244.29.502.29.503.29.510.29.531.29.536.29.507.29.512.29.513.29.519.29.522
- 501: 6/6/23: Compl:5%->45% / Impacted TSs and TRs: 24.501.29.244.29.502.29.503.29.510.29.531.29.536.29.507.29.512.29.513.29.519.29.522
- 502: ; 2/4/24: 0%->100 / Impacted TSs and TRs: 32.255; 32.256; 32.291; 32.298
- 503: 2/1/24: WID:RP-230787->RP-232793
- 504: ; 7/6/23: Compl:0%->30%; 6/9/23: Compl:30%->70%; WID: RP-230787->RP-231396; Stat Rep: ->RP-231889; Rapporteur: ZTE->Dapeng Li, ZTE; Rap eMail: ->Li.dapeng@zte.com.cn; ; 8/12/23: Compl:70%->100%; Stat Rep: RP-231889->RP-232866;
- 505: ; 4/6/22: 0%->35; 12/9/22: 35%->45; 12/9/22: FCD:12/09/2022->06/23; 11/12/22: 45%->55; 17/3/23: 55%->60; 8/6/23: 60%->60; 8/6/23: FCD:09/06/2023->12/24; 7/9/23: 60%->70; 7/9/23: FCD:12/12/2024->12/23; 8/12/23: 70%->100 / Impacted TSs and TRs: 28.531; 28.541
- 506: 5/4/22: 28.836 added;; 11/9/22: FCD:12/09/2022->06/23; 12/9/22: 0%->40; 12/9/22: FCD:12/06/2023->12/22; 11/12/22: 40%->50; 11/12/22: FCD:12/12/2022->/23; 8/6/23: 50%->85; 8/6/23: FCD:06/06/2023->/23; 7/9/23: 85%->85; 7/9/23: FCD:09/09/2023->12/23; 8/12/23: 85%->100 / Impacted TSs and TRs: 28.836
- 507: ; 8/6/23: 0%->40; 8/6/23: 40%->; 7/9/23: 40%->75; 8/12/23: 75%->100; 4/1/24: 28.914 added; / Impacted TSs and TRs: 28.312 ; 28.914
- 508: ; 19/3/21: 0%->10; 9/4/21: FCD:11/06/2021->09/21; 11/6/21: 10%->15; 11/6/21: FCD:Wed 08/09/->12/21; 2/7/21: 33.874 added;; 13/9/21: 15%->30; 13/3/22: Rel-17->Rel-18; 4/6/22: 30%->100 / Impacted TSs and TRs: New ; 33.874
- 509: 3/8/22: 26.941 added; 17/8/22: FS_eNS_Ph3->FS_MS_NS_Ph2; WID:SP-220615->SP-220675; 12/9/22: 0%->15; 11/12/22: 15%->20; 11/12/22: FCD:10/03/2023->/23; 17/3/23: 20%->25; 17/3/23: FCD:06/06/2023->12/23; 8/6/23: 25%->40; 7/9/23: 40%->65; 8/12/23: 65%->100 / Impacted TSs and TRs: 26.941
- 510: 12/3/22: 0%->70; 13/3/22: Rel-17->Rel-18; 4/6/22: 70%->100 / Impacted TSs and TRs: 33.501;
- 511: 2/7/21: 23.700-99 added;; 13/9/21: 0%->25; 13/12/21: 25%->55; 13/12/21: FCD:Fri 11/03/->06/22; 13/12/21: WID:SP-210177->SP-211509; 12/3/22: 55%->70; 4/6/22: 70%->85; 12/9/22: 85%->95; 12/9/22: FCD:10/06/2022->09/22; 11/12/22: 95%->100 / Impacted TSs and TRs: 23.700-99
- 512: ; 13/7/22: 23.435 added;; 12/9/22: 0%->10; 11/12/22: 10%->30; 17/3/23: 30%->70; 8/6/23: 70%->100 / Impacted TSs and TRs: 23.434 ; 23.435
- 513: ; 13/7/22: 23.435 added;; 12/9/22: 0%->10; 11/12/22: 10%->30; 17/3/23: 30%->70; 8/6/23: 70%->100 / Impacted TSs and TRs: 23.434 ; 23.435
- 514: Impacted TSs and TRs: 24.549
- 515: Impacted TSs and TRs: 29.222, 29.520, 29.522, 29.549
- 516: Impacted TSs and TRs: 29.536
- 517: 13/7/22: 31.826 added; / Impacted TSs and TRs: 31.826
- 518: 21/3/21: 0%->15; 13/9/21: 15%->50; 13/9/21: FCD:Fri 10/09/->12/21; 12/3/22: 50%->70; 4/6/22: 70%->75; 4/6/22: FCD:10/12/2021->03/23; 21/6/22: 75%->100. 13/7/22: moved Rel-17->Rel-18, as per Gerald e-mail 21/06/22, 15:03; 12/9/22: 100%->85; 11/12/22: 85...; 17/3/23: 95%->100
- 519: ; 16/3/23: FCD:09/09/2023->12/20; 16/3/23: WID:SP-221159->SP-230176; 17/3/23: 0%->5; 17/3/23: 28.203 added;; 8/6/23: 5%->40; 7/9/23: 40%->50; 8/12/23: 50%->75; 8/12/23: FCD:12/12/2023->/2024; 3/1/24: WID:SP-230176->SP-231448; 14/3/24: 75%->100 / Impacted TSs and TRs: 32.240; 32.290; 32.291; 32.298; 32.297 ; 28.203
- 520: 21/9/23: 31.105 added; / Impacted TSs and TRs: 31.105
- 521: -

| ID | WBS | Task | Type | Duration | Start | Finish | Complete | Remaining | Total slack | Constraint | Resources | Work | Actual work | Acronym | PCG approved | WI rapporteur name | Release | TSG approved | WI rapporteur e-mail | Status Report |
| --- | --- | --- | --- | --- | --- | --- | --- | --- | --- | --- | --- | --- | --- | --- | --- | --- | --- | --- | --- | --- |
| 522 | 289 | **XR (eXtended Reality) enhancements for NR** |  | 1048d | 2021-12-13 A | 2025-12-12 | 55% | 466.55d | 57d |  |  | 8392h | 4656h | NR_XR_enh | 50 | Nokia | Rel-18 | 98 |  |  |
| 523 | 289.1 | Core part: XR (eXtended Reality) enhancements for NR |  | 262d | 2022-12-13 A | 2023-12-12 A | 100% |  |  | finish no earlier than 2023-12-12 | R2 | 2096h | 2096h | NR_XR_enh-Core | 50 | Benoist S bire, Nokia | Rel-18 | 98 | benoist.sebire@nokia.com | RP-232779 |
| 524 | 289.2 | Study on XR (eXtended Reality) enhancements for NR |  | 320d | 2021-12-13 A | 2023-03-03 A | 100% |  |  | finish no earlier than 2023-03-03 | R2 | 2560h | 2560h | FS_NR_XR_enh | 48 | Benoist S bire, Nokia | Rel-18 | 94 | benoist.sebire@nokia.com | RP-230276 |
| 525 | 289.3 | UE Conformance - XR (eXtended Reality) enhancements for NR plus CT1 aspects |  | 467d | 2024-03-03 | 2025-12-12 |  |  | 57d | finish no earlier than 2025-12-12 | R5 | 3736h |  | NR_XR_enh_plus_CT1-UEConTest |  | Nokia | Rel-18 |  |  |  |
| 526 | 290 | **Architecture Enhancements for XR (Extended Reality) and media service** |  | 577d | 2021-12-20 A | 2024-03-03 | 99% | 7.69d | 523d |  |  | 9240h | 5128h | XRM | 50 | Dan WANG, China Mobile | Rel-18 | 99 | wangdanyjy@chinamobile.com |  |
| 527 | 290.1 | Study on architecture enhancement for XR and media services |  | 256d | 2021-12-20 A | 2022-12-12 A | 100% |  |  | finish no earlier than 2022-12-12 | S2 | 2048h | 2048h | FS_XRM | 48 | Dan Wang, China Mobile | Rel-18 | 94 | wangdanyjy@chinamobile.com |  |
| 528 | 290.2 | (Stage 2 for XRM) Architecture Enhancements for XR (Extended Reality) and media service |  | 128d | 2022-12-09 A | 2023-06-06 A | 100% |  |  | finish no earlier than 2023-06-06 | S2 | 1024h | 1024h | XRM | 50 | Dan WANG, China Mobile | Rel-18 | 98 | wangdanyjy@chinamobile.com |  |
| 529 | 290.3 | CT1 aspects of XRM |  | 257d | 2023-03-13 A | 2024-03-03 | 98% | 5.14d | 523d | finish no earlier than 2024-03-03 | C1 | 2056h |  | XRM | 50 | Zhennning Huang, China Mobile | Rel-18 | 99 | huangzhenning@chinamobile.com |  |
| 530 | 290.4 | CT3 aspects of XRM |  | 257d | 2023-03-13 A | 2024-03-03 | 96% | 10.28d | 523d | finish no earlier than 2024-03-03 | C3 | 2056h |  | XRM | 50 | Zhennning Huang, China Mobile | Rel-18 | 99 | huangzhenning@chinamobile.com |  |
| 531 | 290.5 | CT4 aspects of XRM |  | 257d | 2023-03-13 A | 2024-03-03 A | 100% |  |  | finish no earlier than 2024-03-03 | C4 | 2056h | 2056h | XRM | 50 | Zhennning Huang, China Mobile | Rel-18 | 99 | huangzhenning@chinamobile.com |  |
| 532 | 291 | Study on immersive Real-time Communication for WebRTC Phase 2 |  | 519d | 2022-03-10 A | 2024-03-03 A | 100% |  |  | finish no earlier than 2024-03-03 | S4 | 4152h | 4152h | FS_eiRTCW | 48 | Yoshihiro INOUE, NTT | Rel-18 | 95 | Yoshihiro.inoue@ntt-at.co.jp |  |
| 533 | 292 | Immersive Real-time Communication for WebRTC |  | 586d | 2022-03-15 A | 2024-06-06 | 75% | 146.5d | 453d | finish no earlier than 2024-06-06 | S4 | 4688h |  | iRTCW | 48 | Kyunghun Jung, Facebook | Rel-18 | 95 | kyunghun@fb.com |  |
| 534 | 293 | Study on Smartly Tethering AR Glasses |  | 324d | 2022-03-10 A | 2023-06-06 A | 100% |  |  | finish no earlier than 2023-06-06 | S4 | 2592h | 2592h | FS_SmarTAR | 48 | Thomas Stockhammer, Qualcomm Incorporated | Rel-18 | 95 | tsto@qti.qualcomm.com |  |
| 535 | 294 | Media Capabilities for Augmented Reality |  | 519d | 2022-03-10 A | 2024-03-03 A | 100% |  |  | finish no earlier than 2024-03-03 | S4 | 4152h | 4152h | MeCAR | 48 | Emmanuel Thomas, Xiaomi | Rel-18 | 95 | thomase@xiaomi.com |  |
| 536 | 295 | IMS-based AR Conversational Services |  | 528d | 2022-06-03 A | 2024-06-06 | 70% | 158.4d | 453d | finish no earlier than 2024-06-06 | S4 | 4224h |  | IBACS | 49 | Gunkel, Simon, KPN N.V. | Rel-18 | 96 | Simon.Gunkel@tno.nl |  |
| 537 | 296 | Generic architecture for RT and AR/MR |  | 263d | 2022-06-03 A | 2023-06-06 A | 100% |  |  | finish no earlier than 2023-06-06 | S4 | 2104h | 2104h | GA4RTAR | 49 | Hakju Ryan Lee, Samsung | Rel-18 | 96 | hakju00.lee@samsung.com |  |
| 538 | 297 | Real-time Transport Protocol Configurations |  | 458d | 2022-06-03 A | 2024-03-03 A | 100% |  |  | finish no earlier than 2024-03-03 | S4 | 3664h | 3664h | 5G_RTP | 49 | Igor Curcio, Nokia Corporation | Rel-18 | 96 | igor.curcio@nokia.com |  |
| 539 | 298 | Terminal Audio quality performance and Test methods for Immersive Audio Services |  | 1374.88d | 2019-03-07 A | 2024-06-06 | 70% | 412.46d | 453d | finish no earlier than 2024-06-06 | S4 | 10999h |  | ATIAS | 42 | Stéphane Ragot, Orange | Rel-18 | 83 | stephane.ragot@orange.com |  |
| 540 | 299 | **EVS Codec Extension for Immersive Voice and Audio Services** |  | 1764d? | 2017-09-08 A | 2024-06-06 | 71% | 504.84d? | 453d |  |  | 15816h | 945.6h | IVAS_Codec | 39 | Bin Wang, Huawei Technologies Co Ltd | Rel-18 | 77 | binbin.wang@huawei.com |  |
| 541 | 299.1 | EVS Codec Extension for Immersive Voice and Audio Services |  | 1764d? | 2017-09-08 A | 2024-06-06 | 80% | 352.8d? | 453d | finish no earlier than 2024-06-06 | S4 | 14112h | 945.6h | IVAS_Codec | 39 | Bin Wang, Huawei Technologies Co Ltd | Rel-18 | 77 | binbin.wang@huawei.com |  |
| 542 | 299.2 | CT1 aspects of IVAS_Codec |  | 71d? | 2024-03-03 | 2024-06-06 |  |  | 453d | finish no earlier than 2024-06-06 | C1 | 568h |  | IVAS_Codec | 39 | Landais, Bruno, Nokia | Rel-18 | 77 | bruno.landais@nokia.com |  |
| 543 | 299.3 | CT3 aspects of IVAS_Codec |  | 71d? | 2024-03-03 | 2024-06-06 |  |  | 453d | finish no earlier than 2024-06-06 | C3 | 568h |  | IVAS_Codec | 39 | Landais, Bruno, Nokia | Rel-18 | 77 | bruno.landais@nokia.com |  |
| 544 | 299.4 | CT4 aspects of IVAS_Codec |  | 71d? | 2024-03-03 | 2024-06-06 |  |  | 453d | finish no earlier than 2024-06-06 | C4 | 568h |  | IVAS_Codec | 39 | Landais, Bruno, Nokia | Rel-18 | 77 | bruno.landais@nokia.com |  |
| 545 | 300 | Immersive Audio for Split Rendering Scenarios |  | 324d | 2023-03-16 A | 2024-06-06 | 35% | 210.6d | 453d | finish no earlier than 2024-06-06 | S4 | 2592h |  | ISAR | 50 | Stefan Bruhn, Dolby Laboratories Inc | Rel-18 | 99 | stefan.bruhn@dolby.com |  |
| 546 | 301 | Split Rendering Media Service Enabler |  | 528d | 2022-06-03 A | 2024-06-06 | 85% | 79.2d | 453d | finish no earlier than 2024-06-06 | S4 | 4224h |  | SR_MSE | 49 | Bouazizi, Imed, Qualcomm Incorporated | Rel-18 | 96 | bouazizi@qti.qualcomm.com |  |
| 547 | 302 | Study on AR and MR QoE Metrics |  | 458d | 2022-06-03 A | 2024-03-03 A | 100% |  |  | finish no earlier than 2024-03-03 | S4 | 3664h | 3664h | FS_ARMRQoE | 49 | Shuai Gao, chinaunicom | Rel-18 | 96 | gaos30@chinaunicom.cn |  |
| 548 | 303 | Study on Audio Aspects for Glasses-type AR/MR Devices |  | 135d | 2022-06-03 A | 2022-12-08 A | 100% |  |  | finish no earlier than 2022-12-08 | S4 | 1080h | 1080h | FS_Audio_5GSTAR | 49 | Stéphane Ragot, Orange | Rel-18 | 96 | stephane.ragot@orange.com |  |
| 549 | 304 | Rel-18 Transportations (Railways, V2X) | milestone | 0d? | 2016-03-15 A | 2016-03-15 A | 100% |  |  | start no earlier than 2016-03-15 |  |  |  |  |  |  | Rel-18 |  |  |  |
| 550 | 305 | Study on Off-Network for Rail |  | 382d | 2020-06-25 A | 2021-12-10 A | 100% |  |  | finish no earlier than 2021-12-12 | S1 | 3056h | 3056h | FS_OffNetRail | 45 | Guillaume Gach | Rel-18 | 88 | Ext.gach <at> uic.org |  |
| 551 | 306 | Study of Interconnection and Migration Aspects for Railways |  | 321d | 2020-06-25 A | 2021-09-16 A | 100% |  |  | finish no earlier than 2021-09-16 | S6 | 2568h | 2568h | FS_IRail | 45 | Oettl, Martin, Nokia | Rel-18 | 88 | martin.oettl@nokia.com |  |

Notes:
- 522: 29/3/23: WID:RP-223502->RP-230786; 2/1/24: WID:RP-230786->RP-232778
- 523: 17/3/23: Compl:0%->10%; Stat Rep: ->RP-230277; Rapporteur: Nokia->Benoist S bire, Nokia; Rap eMail: ->benoist.sebire@nokia.com; 31/3/23: WID: RP-230786->RP-223502; Stat Rep: RP-230277->RP-230785; ;...; 6/9/23: Compl:45%->68%; Stat Rep: RP-230785->RP-2...; 8/12/23: Compl:68%->100%; Stat Rep: RP-231606->RP-232779;
- 524: TR 38.8xx; basic XR functionality introduced in REL-15 WI NR_newRAT; 22/3/22: Stat Rep: ->RP-220511; 5/4/22: WID:RP-213587->RP-220285 6/6 ; 20/6/22: Rapporteur: Nokia->Benoist S bire, Nokia; Rap eMail: ->benoist.sebire@nokia.com13/7/22: 38.835 add...;...; 17/3/23: Compl:80%->100%; Stat Rep: RP-223429->RP-230276; / Impacted TSs and TRs: 38.835
- 526: Impacted TSs and TRs: 23.501; 23.502; 23.503
- 527: 21/1/22: 23.700-60 added;; 12/3/22: 0%->15; 4/6/22: 15%->40; 4/6/22: FCD:12/09/2022->12/22; 21/6/22: WID:SP-211646->SP-220705; 12/9/22: 40%->75; 10/12/22: 75%->100 / Impacted TSs and TRs: 23.700-60
- 528: 15/3/23: WID:SP-221326->SP-230092; 15/3/23: 0%->55; 8/6/23: 55%->98; 7/9/23: 98%->100 / Impacted TSs and TRs: 23.501; 23.502; 23.503
- 529: 6/6/23: Compl:20%->65%6/6/23: WID: CP-230115->CP-231196; 2/4/24: 0%->98 / Impacted TSs and TRs: 29.122.29.508.29.512.29.514.29.522.29.591.29.281.29.244.29.564
- 530: 6/6/23: Compl:20%->65%6/6/23: WID: CP-230115->CP-231196 / Impacted TSs and TRs: 29.122.29.508.29.512.29.514.29.522.29.591.29.281.29.244.29.564
- 531: 6/6/23: Compl:0%->65%6/6/23: WID: CP-230115->CP-231196 / Impacted TSs and TRs: 29.122.29.508.29.512.29.514.29.522.29.591.29.281.29.244.29.564
- 532: 4/6/22: 0%->10; 17/8/22: FS_iRTCW_Ph2->FS_eiRTCW ; 12/9/22: 10%->30; 16/3/23: WID:SP-220239->SP-230166; 16/3/23: FCD:06/06/2023->3/3/24. Rapporteur changed from Naotaka MORITA, NTT .; 17/3/23: 30%->35; 17/3/23: FCD:03/03/2024->/24; 8/6/23: 35%->45; 7/9...; 14/3/24: 70%->100 / Impacted TSs and TRs: 26.930
- 533: 5/4/22: 26.113 added;; 4/6/22: 0%->5; 12/9/22: 5%->10; 11/12/22: 10%->20; 11/12/22: WID:SP-220241->SP-221032; 17/3/23: 20%->30; 8/6/23: 30%->55; 7/9/23: WID:SP-221032->SP-230977; 7/9/23: FCD:12/12/2023->/24; 8/12/23: 55%->60; 14/3/24: FCD:03/03/2024->/...; 14/3/24: 75%-> / Impacted TSs and TRs: 26.113
- 534: ; 5/4/22: 26.806 added;; 4/6/22: 0%->30; 12/9/22: 30%->40; 12/9/22: FCD:10/03/2023->03/23; 11/12/22: 40%->60; 17/3/23: 60%->70; 17/3/23: FCD:03/03/2023->/23; 8/6/23: 70%->100 / Impacted TSs and TRs: 26.998 ; 26.806
- 535: ; 5/4/22: 26.119 added;; 4/6/22: 0%->8; 12/9/22: 8%->15; 11/12/22: 15%->30; 11/12/22: FCD:10/03/2023->12/23; 17/3/23: 30%->40; 8/6/23: 40%->60; 7/9/23: 60%->65; 7/9/23: FCD:12/12/2023->/24; 8/12/23: 65%->80; 8/12/23: FCD:03/03/2024->/2024; 14/3/24: 80%->100 / Impacted TSs and TRs: 26.511; 26.117; 26.925; 26.XXX ; 26.119
- 536: 3/8/22: 26.264 added; 17/8/22: IMS4AR->IBACS; 17/8/22: WID:SP-220609->SP-220668; 12/9/22: 0%->5; 11/12/22: 5%->15; 11/12/22: FCD:08/12/2023->12/23; 16/3/23: WID:SP-220668->SP-230165; 17/3/23: 15%->20; 8/6/23: 20%->30; 8/6/23: FCD:12/12/2023->03/20; 8/1...; 14/3/24: FCD:03/03/2024->/24 / Impacted TSs and TRs: 26.264
- 537: 17/8/22: GA4RTARMR-> GA4RTAR; 17/8/22: WID:SP-220611->SP-220672; 12/9/22: 0%->25; 11/12/22: 25%->60; 11/12/22: FCD:08/12/2023->03/23; 17/3/23: 60%->70; 17/3/23: FCD:03/03/2023->/23; 8/6/23: 70%->100
- 538: 3/8/22: 26.522 added; 17/8/22: RTPconfig->5G_RTP; 12/9/22: 0%->3; 11/12/22: 3%->7; 11/12/22: FCD:08/06/2023->/23; 17/3/23: 7%->15; 17/3/23: FCD:06/06/2023->12/23; 8/6/23: 15%->35; 8/6/23: FCD:12/12/2023->03/20; 8/6/23: WID:SP-220613->SP-230541; 7/9/23:...; 14/3/24: 60%->100 / Impacted TSs and TRs: 26.522
- 539: 31/5/19: 0%->10; 25/3/20: 10%->15; 5/12/20: 15%->20; 5/12/20: FCD:04/12/2020->12/20. 12/21: Rel-17->Rel-18; 4/6/22: 20%->; 11/12/22: 20%->25; 11/12/22: FCD:02/12/2022->12/23; 17/3/23: 25%->30; 8/6/23: 30%->40; 7/9/23: 40%->50; 7/9/23: FCD:12/12/2023->/...; 14/3/24: FCD:03/03/2024->/24 / Impacted TSs and TRs: 26.260; new
- 540: 15/12/17: 0%->5¦16/3/18: 5%->10¦7/6/18: 10%->15¦10/9/18: 15%->20¦7/3/19: 20%->25; 31/5/19: 25%->30; 13/9/19: FCD:11/12/2020->06/20; 13/9/19: 30%->26; 6/12/19: 26%->27; 5/12…; 12/21: Rel-17->Rel-18; 4/6/22: 30%->35; 12/9/22: 35%->40; 11/12/22: 40%->45; ...; 8/12/23: 75%->78 / Impacted TSs and TRs: 26.114; new; 26.258; 26.256; 26.255; 26.254; 26.253; 26.251; 26.252; 26.250; 26.997
- 541: 15/12/17: 0%->5¦16/3/18: 5%->10¦7/6/18: 10%->15¦10/9/18: 15%->20¦7/3/19: 20%->25; 31/5/19: 25%->30; 13/9/19: FCD:11/12/2020->06/20; 13/9/19: 30%->26; 6/12/19: 26%->27; 5/12…; 12/21: Rel-17->Rel-18; 4/6/22: 30%->35; 12/9/22: 35%->40; 11/12/22: 40%->45; ...; 14/3/24: FCD:03/03/2024->/24 / Impacted TSs and TRs: 26.114; new; 26.258; 26.256; 26.255; 26.254; 26.253; 26.251; 26.252; 26.250; 26.997
- 542: Impacted TSs and TRs: 23.333, 29.333, 23.334, 29.334, 29.162, 29.238, 29.163, 29.332, 29.292, 29.232, 24.229
- 543: Impacted TSs and TRs: 23.333, 29.333, 23.334, 29.334, 29.162, 29.238, 29.163, 29.332, 29.292, 29.232, 24.229
- 544: Impacted TSs and TRs: 23.333, 29.333, 23.334, 29.334, 29.162, 29.238, 29.163, 29.332, 29.292, 29.232, 24.229
- 545: ; 8/6/23: 0%->10; 8/6/23: 26.566 added;; 8/6/23: 26.866 added;; 8/6/23: 26.865 added;; 7/9/23: 10%->15; 8/12/23: 15%->25; 8/12/23: WID:SP-230167->SP-231291; 14/3/24: 25%->35; 14/3/24: FCD:03/03/2024->/24; 3/4/24: 26.249 added; 26.996 added; / Impacted TSs and TRs: 26.119 ; 26.566; 26.866; 26.865; 26.249; 26.996
- 546: 3/8/22: 26.565 added;; 17/8/22: WID:SP-220612->SP-220685; 12/9/22: 0%->5; 11/12/22: 5%->15; 11/12/22: FCD:08/12/2023->09/23; 17/3/23: 15%->25; 17/3/23: FCD:09/09/2023->12/23; 8/6/23: 25%->40; 8/6/23: FCD:12/12/2023->03/20; 7/9/23: 40%->50; 8/12/23: 50%...; 14/3/24: FCD:03/03/2024->/24 / Impacted TSs and TRs: 26.565
- 547: 13/7/22: 26.812 added;; 17/8/22: WID:SP-220616->SP-220708; 12/9/22: 0%->5; 11/12/22: 5%->10; 17/3/23: 10%->15; 8/6/23: 15%->27; 7/9/23: 27%->50; 7/9/23: FCD:12/12/2023->/24; 8/12/23: 50%->65; 14/3/24: 65%->100 / Impacted TSs and TRs: 26.812
- 548: 17/8/22: FS_ARMRglass->FS_Audio_5GSTAR; 12/9/22: 0%->5; 11/12/22: 5%->100 / Impacted TSs and TRs: 26.998;
- 549: -
- 550: 28/7/20: 22.990 added;; 12/9/20: 0%->10; 5/12/20: 10%->30; 19/3/21: FCD:17/03/2021->12/21; 19/3/21: 30%->50; 13/9/21: 50%->90; 10/12/21: 90%->100 / Impacted TSs and TRs: 22.990
- 551: 13/9/20: 0%->10; 25/9/20: 23.700-90 added;; 21/3/21: 10%->15; 11/6/21: 15%->30; 13/9/21: 30%->60; 13/12/21: 60%->85; 12/3/22: 85%->100 / Impacted TSs and TRs: 23.700-90

| ID | WBS | Task | Type | Duration | Start | Finish | Complete | Remaining | Total slack | Constraint | Resources | Work | Actual work | Acronym | PCG approved | WI rapporteur name | WI rapporteur e-mail | Release | TSG approved | Status Report |
| --- | --- | --- | --- | --- | --- | --- | --- | --- | --- | --- | --- | --- | --- | --- | --- | --- | --- | --- | --- | --- |
| 552 | 307 | **Interconnection and Migration Aspects for Railways** |  | 465d | 2022-03-03 A | 2023-12-12 A | 100% |  |  |  |  | 5768h | 5768h | IRail | 48 | Oettl, Martin, Nokia | martin.oettl@nokia.com | Rel-18 | 95 |  |
| 553 | 307.1 | Stage 2 of Irail |  | 203d | 2022-03-03 A | 2022-12-12 A | 100% |  |  | finish no earlier than 2022-12-12 | S6 | 1624h | 1624h | IRail | 48 | Oettl, Martin, Nokia | martin.oettl@nokia.com | Rel-18 | 95 |  |
| 554 | 307.2 | CT1 aspects of eMCSMI_IRail |  | 259d | 2022-12-16 A | 2023-12-12 A | 100% |  |  | finish no earlier than 2023-12-12 | C1 | 2072h | 2072h | eMCSMI_IRail | 48 | Won, Sung Hwan, Nokia | sung.won@nokia.com | Rel-18 | 95 |  |
| 555 | 307.3 | deleted - CT4 aspects of eMCSMI_IRail |  | 259d | 2022-12-16 A | 2023-12-12 A | 100% |  |  | finish no earlier than 2023-12-12 | C4 | 2072h | 2072h | eMCSMI_IRail | 48 | Won, Sung Hwan, Nokia | sung.won@nokia.com | Rel-18 | 95 |  |
| 556 | 308 | Study on FRMCS Phase 4 |  | 266d | 2020-12-04 A | 2021-12-10 A | 100% |  |  | finish no earlier than 2021-12-12 | S1 | 2128h | 2128h | FS_FRMCS_Ph4 | 46 | Guillaume Gach; UIC | Guillaume Gach; gach <at> uic.org | Rel-18 | 90 |  |
| 557 | 309 | Study on enhancements to application layer support for V2X services; Phase 2 |  | 261d | 2021-09-13 A | 2022-09-12 A | 100% |  |  | finish no earlier than 2022-09-12 | S6 | 2088h | 2088h | FS_eV2XAPP2 | 47 | Niranth Amogh, Huawei Telecommunications India | namogh@huawei.com | Rel-18 | 93 |  |
| 558 | 310 | **Application layer support for V2X services; Phase 3** |  | 388d | 2022-09-09 A | 2024-03-03 A | 100% |  |  |  |  | 6632h | 6632h | V2XAPP_Ph3 | 49 | Niranth Amogh, Huawei Telecommunications India | namogh@huawei.com | Rel-18 | 97 |  |
| 559 | 310.1 | Stage 2 of V2XAPP_Ph3 |  | 193d | 2022-09-09 A | 2023-06-06 A | 100% |  |  | finish no earlier than 2023-06-06 | S6 | 1544h | 1544h | V2XAPP_Ph3 | 49 | Niranth Amogh, Huawei Telecommunications India | namogh@huawei.com | Rel-18 | 97 |  |
| 560 | 310.2 | CT1 aspects of V2XAPP_Ph3 |  | 318d | 2022-12-16 A | 2024-03-03 A | 100% |  |  | finish no earlier than 2024-03-03 | C1 | 2544h | 2544h | V2XAPP_Ph3 | 49 | Herrero Veron, Christian (Huawei) | Christian.Herrero at huawei.com | Rel-18 | 97 |  |
| 561 | 310.3 | CT3 aspects of V2XAPP_Ph3 |  | 318d | 2022-12-16 A | 2024-03-03 A | 100% |  |  | finish no earlier than 2024-03-03 | C3 | 2544h | 2544h | V2XAPP_Ph3 | 49 | Herrero Veron, Christian (Huawei) | Christian.Herrero at huawei.com | Rel-18 | 97 |  |
| 562 | 311 | **MBS support for V2X services** |  | 387d | 2022-09-12 A | 2024-03-03 A | 100% |  |  |  |  | 4120h | 4120h | TEI18_MBS4V2X | 49 | LaeYoung Kim (LG Electronics), | laeyoung.kim@lge.com | Rel-18 | 97 |  |
| 563 | 311.1 | (Stage 2 of) MBS support for V2X services |  | 125d | 2022-09-12 A | 2023-03-03 A | 100% |  |  | finish no earlier than 2023-03-03 | S2 | 1000h | 1000h | TEI18_MBS4V2X | 49 | LaeYoung Kim (LG Electronics), | laeyoung.kim@lge.com | Rel-18 | 97 |  |
| 564 | 311.2 | CT1 aspects of MBS support for V2X services |  | 195d | 2023-06-07 A | 2024-03-03 A | 100% |  |  | finish no earlier than 2024-03-03 | C1 | 1560h | 1560h | TEI18_MBS4V2X | 51 | Herrero Veron, Christian (Huawei) | Christian.Herrero at huawei.com | Rel-18 | 100 |  |
| 565 | 311.3 | CT6 aspects of MBS support for V2X services |  | 195d | 2023-06-07 A | 2024-03-03 A | 100% |  |  | finish no earlier than 2024-03-03 | C6 | 1560h | 1560h | TEI18_MBS4V2X | 51 | Herrero Veron, Christian (Huawei) | Christian.Herrero at huawei.com | Rel-18 | 101 |  |
| 566 | 312 | **Enhanced NR support for high speed train scenario in frequency range 2 (FR2)** |  | 982d | 2022-03-15 A | 2025-12-12 | 64% | 358.11d | 57d |  |  | 11528h | 3112h | NR_HST_FR2_enh | 48 | Samsung |  | Rel-18 | 95 |  |
| 567 | 312.1 | Core part: Enhanced NR support for high speed train scenario in frequency range 2 (FR2) |  | 389d | 2022-03-15 A | 2023-09-22 A | 100% |  |  | finish no earlier than 2023-09-22 | R4 | 3112h | 3112h | NR_HST_FR2_enh-Core | 48 | WANG, He (Jackson), Samsung | h0809.wang@samsung.com | Rel-18 | 95 | RP-240367 |
| 568 | 312.2 | Perf. part: Enhanced NR support for high speed train scenario in frequency range 2 (FR2) |  | 585d | 2022-03-16 A | 2024-06-06 | 90% | 58.5d | 453d | finish no earlier than 2024-06-06 | R4 | 4680h |  | NR_HST_FR2_enh-Perf | 48 | WANG, He (Jackson), Samsung | h0809.wang@samsung.com | Rel-18 | 95 | RP-240367 |
| 569 | 312.3 | UE Conformance - Enhanced NR support for high speed train scenario in frequency range 2 (FR2) |  | 467d | 2024-03-03 | 2025-12-12 |  |  | 57d | finish no earlier than 2025-12-12 | R5 | 3736h |  | NR_HST_FR2_enh-UEConTest |  | Samsung |  | Rel-18 |  |  |
| 570 | 313 | Rel-18 User Plane traffic and services | milestone | 0d? | 2016-03-15 A | 2016-03-15 A | 100% |  |  | start no earlier than 2016-03-15 |  |  |  |  |  |  |  | Rel-18 |  |  |
| 571 | 314 | **Evolution of IMS Multimedia Telephony Service** |  | 1165d | 2019-09-19 A | 2024-03-03 | 99% | 5.81d | 523d |  |  | 20584h | 18528h | eMMTEL | 47 | Hu Yue, China Mobile | huyueyjy@chinamobile.com | Rel-18 | 92 |  |
| 572 | 314.1 | Study on evolution of IMS multimedia telephony service |  | 515d | 2019-09-19 A | 2021-09-08 A | 100% |  |  | finish no earlier than 2021-09-08 | S1 | 4120h | 4120h | FS_MMTELin5G | 43 | Yan Di, China Mobile | yandi@chinamobile.com | Rel-18 | 85 |  |
| 573 | 314.2 | Stage 1 of Evolution of IMS Multimedia Telephony Service |  | 131d | 2021-06-11 A | 2021-12-10 A | 100% |  |  | finish no earlier than 2021-12-12 | S1 | 1048h | 1048h | eMMTEL | 47 | Hu Yue, China Mobile | huyueyjy@chinamobile.com | Rel-18 | 92 |  |
| 574 | 314.3 | Study on system architecture for next generation real time communication services |  | 315d | 2021-12-20 A | 2023-03-03 A | 100% |  |  | finish no earlier than 2023-03-03 | S2 | 2520h | 2520h | FS_NG_RTC | 48 | Yi Jiang | jiangyi at chinamobile dot com | Rel-18 | 94 |  |
| 575 | 314.4 | System architecture for Next Generation Real time Communication services |  | 192d | 2022-09-12 A | 2023-06-06 A | 100% |  |  | finish no earlier than 2023-06-06 | S2 | 1536h | 1536h | NG_RTC | 49 | Yi Jiang, China Mobile | jiangyi at chinamobile dot com | Rel-18 | 97 |  |
| 576 | 314.5 | CT1 aspects of NG_RTC |  | 257d | 2023-03-13 A | 2024-03-03 | 95% | 12.85d | 523d | finish no earlier than 2024-03-03 | C1 | 2056h |  | NG_RTC | 49 | Chen Xu, China Mobile | chenxu@chinamobile.com | Rel-18 | 97 |  |
| 577 | 314.6 | CT3 aspects of NG_RTC |  | 257d | 2023-03-13 A | 2024-03-03 A | 100% |  |  | finish no earlier than 2024-03-03 | C3 | 2056h | 2056h | NG_RTC | 49 | Chen Xu, China Mobile | chenxu@chinamobile.com | Rel-18 | 97 |  |
| 578 | 314.7 | CT4 aspects of NG_RTC |  | 257d | 2023-03-13 A | 2024-03-03 A | 100% |  |  | finish no earlier than 2024-03-03 | C4 | 2056h | 2056h | NG_RTC | 49 | Chen Xu, China Mobile | chenxu@chinamobile.com | Rel-18 | 97 |  |
| 579 | 314.8 | CT6 aspects of NG_RTC |  | 257d | 2023-03-13 A | 2024-03-03 A | 100% |  |  | finish no earlier than 2024-03-03 | C6 | 2056h | 2056h | NG_RTC | 49 | Chen Xu, China Mobile | chenxu@chinamobile.com | Rel-18 | 97 |  |
| 580 | 314.9 | Study on security support for Next Generation Real Time Communication services |  | 264d | 2022-06-02 A | 2023-06-06 A | 100% |  |  | finish no earlier than 2023-06-06 | S3 | 2112h | 2112h | FS_NG_RTC_SEC | 49 | Fei, Li, Huawei | Austin.lifei@huawei.com | Rel-18 | 96 |  |
| 581 | 314.10 | Security support for Next Generation Real Time Communication services |  | 128d | 2023-03-16 A | 2023-09-09 A | 100% |  |  | finish no earlier than 2023-09-09 | S3 | 1024h | 1024h | NG_RTC_SEC | 50 | Fei, Li, Huawei | Austin.lifei@huawei.com | Rel-18 | 99 |  |
| 582 | 315 | Charging Aspects of IMS Data Channel |  | 194d | 2023-06-08 A | 2024-03-03 A | 100% |  |  | finish no earlier than 2024-03-03 | S5 | 1552h | 1552h | IDC_CH | 51 | Chen, Ai, China Mobile, | chenai at chinamobile dot com | Rel-18 | 100 |  |

Notes:
- 552: Impacted TSs and TRs: 23.280; 23.281; 23.282; 23.379
- 553: ; 4/6/22: 0%->40; 12/9/22: 40%->60; 11/12/22: 60%->75; 17/3/23: 75%->85; 8/6/23: 85%->100 / Impacted TSs and TRs: 23.280; 23.281; 23.282; 23.379
- 554: 6/6/23: Compl:10%->15% / Impacted TSs and TRs: 24.379; 24.380; 24.282; 24.481; 24.483; 24.484; 24.482; 24.281; 24.581; 24.582; 29.283
- 555: 2/4/24: deleted at 100% / Impacted TSs and TRs: 24.379; 24.380; 24.282; 24.481; 24.483; 24.484; 24.482; 24.281; 24.581; 24.582; 29.283
- 556: 22.989 ; 19/3/21: FCD:12/09/2021->12/21; 19/3/21: 0%->20; 13/9/21: 20%->80; 10/12/21: 80%->100; 21/6/22: WID:SP-201038->SP-220436. FS_eFRMCS -> FS_FRMCS_Ph4
- 557: 13/12/21: 0%->30; 22/3/22: 23.700-64 added;; 4/6/22: 30%->65; 4/6/22: FCD:10/06/2022->09/22; 4/6/22: WID:SP-210956->SP-220466; 12/9/22: 65%->85; 11/12/22: 85%->100 / Impacted TSs and TRs: 23.700-64
- 558: Impacted TSs and TRs: 23.286; 23.434
- 559: ; 11/12/22: 0%->45; 9/1/23: WID:SP-220916->SP-221229; 17/3/23: 45%->75; 17/3/23: FCD:03/03/2023->/23; 8/6/23: 75%->100 / Impacted TSs and TRs: 23.286; 23.434
- 560: 6/6/23: Compl:0%->20%; 30/6/23: WID:CP-223107->CP-231285 / Impacted TSs and TRs: 24.486; 24.544; 24.545; 24.546; 24.547; 24.548; 29.549; 29.486; 24.549; 29.558
- 561: Impacted TSs and TRs: 24.486; 24.544; 24.545; 24.546; 24.547; 24.548; 29.549; 29.486; 24.549; 29.558
- 562: ; 22/3/23: 0%->100 / Impacted TSs and TRs: 23.287; 23.501
- 563: ; 22/3/23: 0%->100 / Impacted TSs and TRs: 23.287; 23.501
- 564: Impacted TSs and TRs: 24.587; 24.588; 31.102
- 565: Impacted TSs and TRs: 24.587; 24.588; 31.102
- 566: compare REL-17 WI NR_HST_FR2 ; 23/9/22: WID:RP-220985->RP-222272
- 567: compare REL-17 WI NR_HST_FR2 ; 6/6/22: CD:15/09/2023->23/09/2022 ; 6/6/22: Stat Rep: ->RP-221405; 20/6/22: Rapporteur: Samsung->WANG, He (Jackson), Samsung; Rap eMail: ->h0809.wang@samsung.com13/7/22: FCD:23/09/2022->09/20 ...; 9/12/22: FCD:23/09/202...; 14/3/24: FCD:09/09/2023->08/09/2023; Stat Rep: RP-233146->RP-240367;
- 568: 6/6/22: CD:15/03/2024->24/03/2023 6/6/22: Stat Rep: ->RP-221405; 20/6/22: Rapporteur: Samsung->WANG, He (Jackson), Samsung; Rap eMail: ->h0809.wang@samsung.com13/7/22: FCD:24/03/2023->03/20 ; ...; 9/12/22: FCD:24/03/2023->01/03/2024; Stat Rep: RP-...; 14/3/24: FCD:01/03/2024->06/06/2024; Compl:80%->90%; WID: RP-233151->RP-222272; Stat Rep: RP-233146->RP-240367;
- 570: -
- 571: Impacted TSs and TRs: 22.261;22.173
- 572: ; 8/10/19: 22.873 added;; 6/12/19: 0%->10; 12/9/20: 10%->15; 5/12/20: 15%->40; 19/3/21: 40%->75; 19/3/21: FCD:11/12/2020->09/21; 11/6/21: 75%->95; 13/9/21: 95%->100 / Impacted TSs and TRs: New ; 22.873
- 573: ; 13/9/21: 0%->100 / Impacted TSs and TRs: 22.261;22.173
- 574: 21/1/22: 23.700-87 added;; 12/3/22: 0%->20; 5/4/22: WID:SP-211644->SP-220288; 4/6/22: 20%->55; 12/9/22: 55%->79; 12/9/22: FCD:12/09/2022->12/22; 10/12/22: 79%->85; 15/3/23: 85%->100; 16/3/23: FCD:12/12/2022->/23 / Impacted TSs and TRs: 23.700-87
- 575: ; 15/3/23: WID:SP-220804->SP-230098; 15/3/23: 0%->60; 15/3/23: FCD:03/03/2023->/23; 8/6/23: 60%->100 / Impacted TSs and TRs: 23.228; 23.502
- 576: ; 31/3/23: 24.186 added;6/6/23: Compl:0%->15% / Impacted TSs and TRs: 24.229.24.275.29.214.29.514.29.165.29.510.29.562.29.228.29.229.29.328.29.329.29.364.29.333.23.333; 24.186
- 577: Impacted TSs and TRs: 24.229.24.275.29.214.29.514.29.165.29.510.29.562.29.228.29.229.29.328.29.329.29.364.29.333.23.333
- 578: ; 31/3/23: 29.176 added;; 31/3/23: 29.175 added;6/6/23: Compl:0%->25%; 4/1/24: 29.330 added; / Impacted TSs and TRs: 24.229.24.275.29.214.29.514.29.165.29.510.29.562.29.228.29.229.29.328.29.329.29.364.29.333.23.333; 29.176; 29.175; 29.330
- 579: ; 31/3/23: 29.176 added;; 31/3/23: 29.175 added;6/6/23: Compl:0%->25%; 4/1/24: 29.330 added; / Impacted TSs and TRs: 24.229.24.275.29.214.29.514.29.165.29.510.29.562.29.228.29.229.29.328.29.329.29.364.29.333.23.333; 29.176; 29.175; 29.330
- 580: 13/7/22: 33.890 added;; 12/9/22: 0%->40; 11/12/22: 40%->70; 17/3/23: 70%->90; 8/6/23: 90%->100 / Impacted TSs and TRs: 33.890
- 581: ; 15/3/24: 0%->100 / Impacted TSs and TRs: 33.328
- 582: ; 8/12/23: 0%->40; 14/3/24: 40%->100 / Impacted TSs and TRs: 32.260; 32.255; 32.291; 32.298

| ID | WBS | Task | Type | Duration | Start | Finish | Complete | Remaining | Total slack | Constraint | Resources | Work | Actual work | Acronym | PCG approved | WI rapporteur name | WI rapporteur e-mail | Release | TSG approved |
| --- | --- | --- | --- | --- | --- | --- | --- | --- | --- | --- | --- | --- | --- | --- | --- | --- | --- | --- | --- |
| 583 | 316 | **Access Traffic Steering, Switch and Splitting support in the 5G system architecture; Phase 3** |  | 577d | 2021-12-20 A | 2024-03-03 A | 100% |  |  |  |  | 9752h | 9752h | ATSSS_Ph3 | 49 | Apostolis Salkintzis, Lenovo | y1026c@lenovo.com | Rel-18 | 97 |
| 584 | 316.1 | Study on Access Traffic Steering, Switching and Splitting support in the 5G system architecture; Phase 3 |  | 256d | 2021-12-20 A | 2022-12-12 A | 100% |  |  | finish no earlier than 2022-12-12 | S2 | 2048h | 2048h | FS_ATSSS_Ph3 | 48 | Salkintzis, Apostolis, Lenovo, | y1026c@lenovo.com | Rel-18 | 94 |
| 585 | 316.2 | Stage 2 of ATSSS_Ph3 |  | 192d | 2022-09-12 A | 2023-06-06 A | 100% |  |  | finish no earlier than 2023-06-06 | S2 | 1536h | 1536h | ATSSS_Ph3 | 49 | Apostolis Salkintzis, Lenovo | y1026c@lenovo.com | Rel-18 | 97 |
| 586 | 316.3 | CT1 aspects of ATSSS_Ph3 |  | 257d | 2023-03-13 A | 2024-03-03 A | 100% |  |  | finish no earlier than 2024-03-03 | C1 | 2056h | 2056h | ATSSS_Ph3 | 49 | Atarius, Roozbeh, Lenovo | ratarius@motorola.com | Rel-18 | 97 |
| 587 | 316.4 | CT3 aspects of ATSSS_Ph3 |  | 257d | 2023-03-13 A | 2024-03-03 A | 100% |  |  | finish no earlier than 2024-03-03 | C3 | 2056h | 2056h | ATSSS_Ph3 | 49 | Atarius, Roozbeh, Lenovo | ratarius@motorola.com | Rel-18 | 97 |
| 588 | 316.5 | CT4 aspects of ATSSS_Ph3 |  | 257d | 2023-03-13 A | 2024-03-03 A | 100% |  |  | finish no earlier than 2024-03-03 | C4 | 2056h | 2056h | ATSSS_Ph3 | 49 | Atarius, Roozbeh, Lenovo | ratarius@motorola.com | Rel-18 | 97 |
| 589 | 317 | Study on UPF enhancement for Exposure And SBA |  | 256d | 2021-12-20 A | 2022-12-12 A | 100% |  |  | finish no earlier than 2022-12-12 | S2 | 2048h | 2048h | FS_UPEAS | 48 | Yan Han, China Mobile | hanyan@chinamobile.com | Rel-18 | 94 |
| 590 | 318 | **UPF enhancement for Exposure and SBA** |  | 387d | 2022-09-12 A | 2024-03-03 A | 100% |  |  |  |  | 5232h | 5232h | UPEAS | 49 | Yan Han, China Mobile | hanyan@chinamobile.com | Rel-18 | 97 |
| 591 | 318.1 | Stage 2 of UPEAS |  | 192d | 2022-09-12 A | 2023-06-06 A | 100% |  |  | finish no earlier than 2023-06-06 | S2 | 1536h | 1536h | UPEAS | 49 | Yan Han, China Mobile | hanyan@chinamobile.com | Rel-18 | 97 |
| 592 | 318.2 | CT4 aspects of UPF enhancement for exposure and SBA |  | 231d | 2023-03-13 A | 2024-03-03 A | 100% |  |  | finish no earlier than 2024-03-03 | C4 | 1848h | 1848h | UPEAS | 49 | Rong Wang, China Mobile | wangrongyjy@chinamobile.com | Rel-18 | 97 |
| 593 | 318.3 | CT3 aspects of UPF enhancement for exposure and SBA |  | 231d | 2023-04-18 A | 2024-03-03 A | 100% |  |  | finish no earlier than 2024-03-03 | C3 | 1848h | 1848h | UPEAS | 49 | Rong Wang, China Mobile | wangrongyjy@chinamobile.com | Rel-18 | 97 |
| 594 | 319 | **Tactile and multi-modality communication services** |  | 266d | 2020-12-04 A | 2021-12-10 A | 100% |  |  |  |  | 1616h | 1616h | TACMM | 47 | Xiaonan Shi, CMCC | shixiaonan@chinamobile.com | Rel-18 | 93 |
| 595 | 319.1 | Study on TACMM |  | 136d | 2020-12-04 A | 2021-06-11 A | 100% |  |  | finish no earlier than 2021-06-12 | S1 | 1088h | 1088h | FS_TACMM | 46 | Shi, Xiaonan, China Mobile | shixiaonan@chinamobile.com | Rel-18 | 90 |
| 596 | 319.2 | Stage 1 of TACMM |  | 66d | 2021-09-10 A | 2021-12-10 A | 100% |  |  | finish no earlier than 2021-12-12 | S1 | 528h | 528h | TACMM | 47 | Xiaonan Shi, CMCC | shixiaonan@chinamobile.com | Rel-18 | 93 |
| 597 | 320 | Rel-18 Edge computing | milestone | 0d? | 2016-03-15 A | 2016-03-15 A | 100% |  |  | start no earlier than 2016-03-15 |  |  |  |  |  |  |  | Rel-18 |  |
| 598 | 321 | **Architecture for enabling Edge Applications Phase 2** |  | 329d | 2022-09-09 A | 2023-12-12 | 95% | 17.21d | 582d |  |  | 5167.84h | 1111.84h | EDGEAPP_Ph2 | 49 | Sapan Shah, Samsung | sapan.shah@samsung.com | Rel-18 | 97 |
| 599 | 321.1 | (Stage 2 of EDGEAPP_Ph2) Architecture for enabling Edge Applications Phase 2 |  | 125.98d | 2022-09-09 A | 2023-03-03 A | 100% |  |  | finish no earlier than 2023-03-03 | S6 | 1007.84h | 1007.84h | EDGEAPP_Ph2 | 49 | Sapan Shah, Samsung | sapan.shah@samsung.com | Rel-18 | 97 |
| 600 | 321.2 | CT1 aspects of EDGEAPP_Ph2 |  | 260d | 2022-12-15 A | 2023-12-12 | 97% | 7.8d | 582d | finish no earlier than 2023-12-12 | C1 | 2080h | 52h | EDGEAPP_Ph2 | 49 | Narendranath Durga Tangudu | n.tangudu@samsung.com | Rel-18 | 97 |
| 601 | 321.3 | CT3 aspects of EDGEAPP_Ph2 |  | 260d | 2022-12-15 A | 2023-12-12 | 90% | 26d | 582d | finish no earlier than 2023-12-12 | C3 | 2080h | 52h | EDGEAPP_Ph2 | 49 | Narendranath Durga Tangudu | n.tangudu@samsung.com | Rel-18 | 97 |
| 602 | 322 | Edge Application Standards in 3GPP and alignment with External Organizations |  | 400d | 2022-06-02 A | 2023-12-12 | 98% | 8d | 582d | finish no earlier than 2023-12-12 | S6 | 3200h |  | EDGEAPP_EXT | 49 | Meghashree Dattatri Kedalagudde, Intel | meghashree.dattatri.kedalagudde@intel.com | Rel-18 | 96 |
| 603 | 323 | Study on enhanced architecture for enabling Edge Applications |  | 261d | 2021-06-11 A | 2022-06-10 A | 100% |  |  | finish no earlier than 2022-06-12 | S6 | 2088h | 2088h | FS_eEDGEAPP | 47 | Gupta, Nishant, Samsung | nishant.gup@samsung.com | Rel-18 | 92 |
| 604 | 324 | **Edge Computing Phase 2** |  | 518d | 2021-12-20 A | 2023-12-12 | 99% | 5.22d | 582d |  |  | 12312h | 8168h | FS_EDGE_Ph2 | 48 | Patrice Hédé, Huawei Technologies | patrice dot hede at huawei dot com | Rel-18 | 95 |
| 605 | 324.1 | Study on Edge Computing phase 2 |  | 256d | 2021-12-20 A | 2022-12-12 A | 100% |  |  |  | S2 | 2048h | 2048h | FS_EDGE_Ph2 | 48 | Patrice Hédé, Huawei Technologies | patrice dot hede at huawei dot com | Rel-18 | 95 |
| 606 | 324.2 | Study on Stage 2 of Edge Computing phase 2 |  | 256d | 2021-12-20 A | 2022-12-12 A | 100% |  |  | finish no earlier than 2022-12-12 | S2 | 2048h | 2048h | FS_EDGE_Ph2 | 48 | Patrice Hédé, Huawei Technologies | patrice dot hede at huawei dot com | Rel-18 | 94 |
| 607 | 324.3 | Study on Security of Edge Computing phase 2 |  | 198d | 2022-03-10 A | 2022-12-12 A | 100% |  |  | finish no earlier than 2022-12-12 | S3 | 1584h | 1584h | FS_EDGE_Ph2 | 48 | Bo Zhang, Huawei | zhangbo6@huawei.com | Rel-18 | 95 |
| 608 | 324.4 | (stage 2 of) Edge Computing Phase 2 |  | 183d | 2022-09-23 A | 2023-06-06 A | 100% |  |  | finish no earlier than 2023-06-06 | S2 | 1464h | 1464h | EDGE_Ph2 | 49 | Patrice Hédé, Huawei Technologies | patrice dot hede at huawei dot com | Rel-18 | 97 |
| 609 | 324.5 | CT3 aspects of EDGE_Ph2 |  | 259d | 2022-12-16 A | 2023-12-12 | 96% | 10.36d | 582d | finish no earlier than 2023-12-12 | C3 | 2072h |  | EDGE_Ph2 | 49 | Qi Caixia, Huawei | caixia.qi@huawei.com | Rel-18 | 97 |
| 610 | 324.6 | CT4 aspects of EDGE_Ph2 |  | 259d | 2022-12-16 A | 2023-12-12 | 98% | 5.18d | 582d | finish no earlier than 2023-12-12 | C4 | 2072h |  | EDGE_Ph2 | 49 | Qi Caixia, Huawei | caixia.qi@huawei.com | Rel-18 | 97 |
| 611 | 324.7 | Security Aspects of Support for Edge Computing in 5GC phase 2 |  | 128d | 2023-03-16 A | 2023-09-09 A | 100% |  |  | finish no earlier than 2023-09-09 | S3 | 1024h | 1024h | EDGE_Ph2 | 50 | Bo Zhang, Huawei Technologies | zhangbo6@huawei.com | Rel-18 | 99 |
| 612 | 325 | Rel-18 Non-Public Networks | milestone | 0d? | 2016-03-15 A | 2016-03-15 A | 100% |  |  | start no earlier than 2016-03-15 |  |  |  |  |  |  |  | Rel-18 |  |

Notes:
- 583: ; 9/1/23: WID:SP-220813->SP-221334 / Impacted TSs and TRs: 23.501; 23.502; 23.503
- 584: 21/1/22: 23.700-53 added;; 12/3/22: 0%->20; 4/6/22: 20%->70; 12/9/22: 70%->80; 12/9/22: FCD:12/09/2022->12/22; 10/12/22: 80%->100 / Impacted TSs and TRs: 23.700-53
- 585: ; 9/1/23: WID:SP-220813->SP-221334; 15/3/23: 0%->85; 15/3/23: FCD:03/03/2023->/23; 8/6/23: 85%->100 / Impacted TSs and TRs: 23.501; 23.502; 23.503
- 586: 6/6/23: Compl:0%->50% / Impacted TSs and TRs: 24.193.24.501.24.302.29.512.29.244.29.502.29.518.29.274.29.571.29.510
- 587: 9/6/23: 0%->60 / Impacted TSs and TRs: 24.193.24.501.24.302.29.512.29.244.29.502.29.518.29.274.29.571.29.510
- 588: 6/6/23: Compl:5%->50% / Impacted TSs and TRs: 24.193.24.501.24.302.29.512.29.244.29.502.29.518.29.274.29.571.29.510
- 589: 21/1/22: 23.700-62 added;; 12/3/22: 0%->20; 4/6/22: 20%->60; 4/6/22: FCD:12/09/2022->12/22; 21/6/22: WID:SP-211652->SP-220417; 12/9/22: 60%->80; 10/12/22: 80%->98; 15/3/23: 98%->100 / Impacted TSs and TRs: 23.700-62
- 590: ; 10/12/22: 0%->20 / Impacted TSs and TRs: 23.501; 23.502; 23.503
- 591: ; 10/12/22: 0%->20; 15/3/23: WID:SP-220809->SP-230103; 15/3/23: 20%->75; 15/3/23: FCD:03/03/2023->/23; 8/6/23: 75%->100 / Impacted TSs and TRs: 23.501; 23.502; 23.503
- 592: 17/3/23: 10%->406/6/23: Compl:40%->70% / Impacted TSs and TRs: 29.510.29.564.29.244.29.571.29.508.29.522.29.512.29.513.29.514.29.565.29.574.29.575.29.552
- 593: 9/6/23: 0%->90 / Impacted TSs and TRs: 29.510.29.564.29.244.29.571.29.508.29.522.29.512.29.513.29.514.29.565.29.574.29.575.29.552
- 594: Impacted TSs and TRs: 22.261
- 595: 10/2/21: 22.847 added;; 19/3/21: 0%->30; 11/6/21: 30%->40; 13/9/21: 40%->85; 14/9/21: WID:SP-201039->SP-210209; 10/12/21: 85%->100 / Impacted TSs and TRs: 22.847
- 596: ; 10/12/21: 0%->100 / Impacted TSs and TRs: 22.261
- 597: -
- 599: ; 12/9/22: 0%->5; 11/12/22: 0%->30; 9/1/23: WID:SP-220917->SP-221231; 17/3/23: 30%->70; 8/6/23: 70%->100 / Impacted TSs and TRs: 23.558; 23.958
- 600: ; 6/6/23: Compl:5%->40%; 6/6/23: WID: CP-223207->CP-231197 / Impacted TSs and TRs: 24.558; 29.558; 29.222
- 601: ; 6/6/23: Compl:10%->40%; 6/6/23: WID: CP-223207->CP-231197 / Impacted TSs and TRs: 24.558; 29.558; 29.222
- 602: 13/7/22: 23.958 added;; 12/9/22: 0%->5; 12/9/22: WID:SP-220468->SP-220912; 17/3/23: 5%->10; 8/6/23: 10%->50; 7/9/23: 50%->65; 13/9/23: FCD:06/06/2023->12/20; 13/9/23: WID:SP-220990->SP-231156; 15/3/24: 65%->98 / Impacted TSs and TRs: 23.958
- 603: 2/7/21: 23.700-98 added;; 13/9/21: 0%->10; 13/12/21: 10%->45; 13/12/21: WID:SP-210479->SP-211510; 13/12/21: FCD:Fri 11/03/->06/22; 12/3/22: 45%->55; 4/6/22: 55%->75; 12/9/22: 75%->90; 11/12/22: 90%->100 / Impacted TSs and TRs: 23.700-98
- 604: 21/1/22: 23.700-48 added;; 12/3/22: 0%->13; 12/3/22: FCD:12/09/2022->12/22; 12/3/22: WID:SP-211638->SP-220070 / Impacted TSs and TRs: 23.700-48
- 605: 21/1/22: 23.700-48 added;; 12/3/22: 0%->13; 12/3/22: FCD:12/09/2022->12/22; 12/3/22: WID:SP-211638->SP-220070 / Impacted TSs and TRs: 23.700-48
- 606: 21/1/22: 23.700-48 added;; 12/3/22: 0%->13; 12/3/22: FCD:12/09/2022->12/22; 12/3/22: WID:SP-211638->SP-220070; 4/6/22: 13%->55; 12/9/22: 55%->83; 10/12/22: 83%->100 / Impacted TSs and TRs: 23.700-48
- 607: 4/6/22: 0%->30; 13/7/22: 33.739 added;; 12/9/22: 30%->40; 11/12/22: 40%->70; 17/3/23: 70%->80; 8/6/23: 80%->90; 15/3/24: 90%->100 / Impacted TSs and TRs: 33.739
- 608: ; 10/12/22: 0%->15; 9/1/23: WID:SP-220987->SP-221337; 15/3/23: WID:SP-221337->SP-230112; 15/3/23: 15%->80; 15/3/23: FCD:03/03/2023->/23; 8/6/23: 80%->100 / Impacted TSs and TRs: 23.548; 23.501; 23.502; 23.503
- 609: 9/6/23: 30%->35 / Impacted TSs and TRs: 29.510; 29.502; 29.503; 29.504; 29.505; 29.571; 29.556; 29.508; 29.512; 29.514; 29.513; 29.522; 29.519
- 610: ; 6/6/23: Compl:20%->45% / Impacted TSs and TRs: 29.510; 29.502; 29.503; 29.504; 29.505; 29.571; 29.556; 29.508; 29.512; 29.514; 29.513; 29.522; 29.519
- 611: 31/3/23: WID:SP-230152->SP-230366; 7/9/23: 0%->95; 15/3/24: 95%->100 / Impacted TSs and TRs: 33.558; 33.501
- 612: -

| ID | WBS | Task | Type | Duration | Start | Finish | Complete | Remaining | Total slack | Constraint | Resources | Work | Actual work | Acronym | PCG approved | WI rapporteur name | WI rapporteur e-mail | Release | TSG approved | Status Report |
| --- | --- | --- | --- | --- | --- | --- | --- | --- | --- | --- | --- | --- | --- | --- | --- | --- | --- | --- | --- | --- |
| 613 | 326 | **5G Networks Providing Access to Localized Services** |  | 256d | 2020-09-16 A | 2021-09-08 A | 100% |  |  |  |  | 2056h | 2056h | PALS | 47 | Lola Awoniyi-Oteri, qualcomm | oawoniyi@qti.qualcomm.com | Rel-18 | 92 |  |
| 614 | 326.1 | Study on PALS |  | 193d | 2020-09-16 A | 2021-06-11 A | 100% |  |  | finish no earlier than 2021-06-11 | S1 | 1544h | 1544h | FS_PALS | 45 | Jack Nasielski | jackn <at> qti.qualcomm.com | Rel-18 | 89 |  |
| 615 | 326.2 | Stage 1 of PALS |  | 64d | 2021-06-11 A | 2021-09-08 A | 100% |  |  | finish no earlier than 2021-09-08 | S1 | 512h | 512h | PALS | 47 | Lola Awoniyi-Oteri, qualcomm | oawoniyi@qti.qualcomm.com | Rel-18 | 92 |  |
| 616 | 327 | **Non-Public Networks Phase 2** |  | 582d | 2021-12-13 A | 2024-03-03 A | 100% |  |  |  |  | 20048h | 20048h | eNPN_Ph2 | 49 | Hedman, Peter, Ericsson | peter . hedman @ ericsson . com | Rel-18 | 97 |  |
| 617 | 327.1 | Study on enhanced support of Non-Public Networks phase 2 |  | 256d | 2021-12-20 A | 2022-12-12 A | 100% |  |  | finish no earlier than 2022-12-12 | S2 | 2048h | 2048h | FS_eNPN_Ph2 | 48 | Hedman, Peter, Ericsson | peter . hedman @ ericsson . com | Rel-18 | 94 |  |
| 618 | 327.2 | Stage 2 of Non-Public Networks Phase 2 |  | 192d | 2022-09-12 A | 2023-06-06 A | 100% |  |  | finish no earlier than 2023-06-06 | S2 | 1536h | 1536h | eNPN_Ph2 | 49 | Hedman, Peter, Ericsson | peter . hedman @ ericsson . com | Rel-18 | 97 |  |
| 619 | 327.3 | Study on security aspects of enhanced support of Non-Public Networks phase 2 |  | 197d | 2022-06-02 A | 2023-03-03 A | 100% |  |  | finish no earlier than 2023-03-03 | S3 | 1576h | 1576h | FS_eNPN_Ph2_SEC | 49 | Jost, Christine, Ericsson, | (christine.jost@ericsson.com) | Rel-18 | 96 |  |
| 620 | 327.4 | Security aspects of support of Non-Public Networks phase 2 |  | 128d | 2023-03-16 A | 2023-09-09 A | 100% |  |  | finish no earlier than 2023-09-09 | S3 | 1024h | 1024h | eNPN_Ph2 | 50 | Jost, Christine, Ericsson | christine.jost@ericsson.com | Rel-18 | 99 |  |
| 621 | 327.5 | CT1 aspects of eNPN_Ph2 |  | 318d | 2022-12-16 A | 2024-03-03 A | 100% |  |  | finish no earlier than 2024-03-03 | C1 | 2544h | 2544h | eNPN_Ph2 | 49 | Sedlacek, Ivo, Ericsson | ivo <dot> sedlacek <at> ericsson <dot> com | Rel-18 | 97 |  |
| 622 | 327.6 | CT3 aspects of eNPN_Ph2 |  | 319d | 2022-12-15 A | 2024-03-03 A | 100% |  |  | finish no earlier than 2024-03-03 | C3 | 2552h | 2552h | eNPN_Ph2 | 49 | Sedlacek, Ivo, Ericsson | ivo <dot> sedlacek <at> ericsson <dot> com | Rel-18 | 97 |  |
| 623 | 327.7 | CT4 aspects of eNPN_Ph2 |  | 319d | 2022-12-15 A | 2024-03-03 A | 100% |  |  | finish no earlier than 2024-03-03 | C4 | 2552h | 2552h | eNPN_Ph2 | 49 | Sedlacek, Ivo, Ericsson | ivo <dot> sedlacek <at> ericsson <dot> com | Rel-18 | 97 |  |
| 624 | 327.8 | Study on Charging Aspects for Enhanced Support of Non-Public Networks |  | 320d | 2021-12-13 A | 2023-03-03 A | 100% |  |  | finish no earlier than 2023-03-03 | S5 | 2560h | 2560h | FS_eNPN_CH | 48 | Chen, Ai, China Mobile | chenai@chinamobile.com | Rel-18 | 94 |  |
| 625 | 327.9 | Charging Aspects for Enhanced Support of Non-Public Networks |  | 254d | 2023-03-16 A | 2024-03-03 A | 100% |  |  | finish no earlier than 2024-03-03 | S5 | 2032h | 2032h | eNPN_CH | 50 | Chen, Ai, China Mobile | chenai at chinamobile dot com | Rel-18 | 99 |  |
| 626 | 327.10 | Core part: Non-Public Networks Phase 2: NG-RAN aspects |  | 203d | 2023-03-06 A | 2023-12-12 A | 100% |  |  | finish no earlier than 2023-12-12 | R3 | 1624h | 1624h | eNPN_Ph2-NGRAN-Core | 50 | Shengnan Liu, China Telecom | liushn@chinatelecom.cn | Rel-18 | 99 | RP-233567 |
| 627 | 328 | Rel-18 AM and UE Policy | milestone | 0d? | 2016-03-15 A | 2016-03-15 A | 100% |  |  | start no earlier than 2016-03-15 |  |  |  |  |  |  |  | Rel-18 |  |  |
| 628 | 329 | Study on enhancement of 5G UE Policy |  | 256d | 2021-12-20 A | 2022-12-12 A | 100% |  |  | finish no earlier than 2022-12-12 | S2 | 2048h | 2048h | FS_eUEPO | 43 | Changhong Shan, Intel | chang.hong.shan@intel.com | Rel-18 | 84 |  |
| 629 | 330 | **Enhancement of 5G UE Policy** |  | 388d | 2022-09-09 A | 2024-03-03 | 98% | 6.45d | 523d |  |  | 9176h | 1751.2h | eUEPO | 49 | Changhong Shan, Intel | chang.hong.shan@intel.com | Rel-18 | 97 |  |
| 630 | 330.1 | (Stage 2 of) Enhancement of 5G UE Policy |  | 193d | 2022-09-09 A | 2023-06-06 A | 100% |  |  | finish no earlier than 2023-06-06 | S2 | 1544h | 1544h | eUEPO | 49 | Changhong Shan, Intel | chang.hong.shan@intel.com | Rel-18 | 97 |  |
| 631 | 330.2 | CT1 aspects of eUEPO |  | 318d | 2022-12-16 A | 2024-03-03 | 98% | 6.36d | 523d | finish no earlier than 2024-03-03 | C1 | 2544h |  | eUEPO | 49 | Thomas Luetzenkirchen, Intel | thomas.luetzenkirchen@intel.com | Rel-18 | 97 |  |
| 632 | 330.3 | CT3 aspects of eUEPO |  | 318d | 2022-12-16 A | 2024-03-03 | 98% | 6.36d | 523d | finish no earlier than 2024-03-03 | C3 | 2544h |  | eUEPO | 49 | Thomas Luetzenkirchen, Intel | thomas.luetzenkirchen@intel.com | Rel-18 | 97 |  |
| 633 | 330.4 | CT4 aspects of eUEPO |  | 318d | 2022-12-16 A | 2024-03-03 | 98% | 6.36d | 523d | finish no earlier than 2024-03-03 | C4 | 2544h | 207.2h | eUEPO | 49 | Thomas Luetzenkirchen, Intel | thomas.luetzenkirchen@intel.com | Rel-18 | 97 |  |
| 634 | 331 | **Spending Limits for AM and UE Policies in the 5GC** |  | 328d | 2022-09-12 A | 2023-12-12 A | 100% |  |  |  |  | 3712h | 3712h | TEI18_SLAMUP | 49 | Baniel, Uriuri dot baniel at oracle dot com | uri dot baniel at oracle dot com | Rel-18 | 97 |  |
| 635 | 331.1 | Stage 2 of TEI18_SLAMUP |  | 192d | 2022-09-12 A | 2023-06-06 A | 100% |  |  | finish no earlier than 2023-06-06 | S2 | 1536h | 1536h | TEI18_SLAMUP | 49 | Baniel, Uriuri dot baniel at oracle dot com | uri dot baniel at oracle dot com | Rel-18 | 97 |  |
| 636 | 331.2 | CT3 aspects on TEI18_SLAMUP |  | 136d | 2023-06-07 A | 2023-12-12 A | 100% |  |  | finish no earlier than 2023-12-12 | C3 | 1088h | 1088h | TEI18_SLAMUP | 51 | SUN, Yue, China Telecom | suny20@chinatelecom.cn | Rel-18 | 100 |  |
| 637 | 331.3 | CT4 aspects on TEI18_SLAMUP |  | 136d | 2023-06-07 A | 2023-12-12 A | 100% |  |  | finish no earlier than 2023-12-12 | C4 | 1088h | 1088h | TEI18_SLAMUP | 52 | SUN, Yue, China Telecom | suny20@chinatelecom.cn | Rel-18 | 102 |  |

Notes:
- 613: Impacted TSs and TRs: 22.261
- 614: 5/12/20: 0%->35; 19/3/21: 35%->77; 11/6/21: 77%->95; 13/9/21: 95%->100 / Impacted TSs and TRs: 22.844
- 615: ; 10/12/21: 0%->100 / Impacted TSs and TRs: 22.261
- 616: ; 10/12/22: 0%->50 / Impacted TSs and TRs: 23.501; 23.502; 23.402
- 617: 21/1/22: 23.700-08 added;; 12/3/22: 0%->10; 4/6/22: 10%->50; 4/6/22: FCD:12/09/2022->12/22; 21/6/22: WID:SP-211656->SP-220418; 12/9/22: 50%->75; 12/9/22: FCD:12/12/2022->12/22; 10/12/22: 75%->98; 15/3/23: 98%->100 / Impacted TSs and TRs: 23.700-08
- 618: ; 10/12/22: 0%->50; 9/1/23: WID:SP-220805->SP-221340; 15/3/23: 50%->90; 15/3/23: WID:SP-221340->SP-230096; 15/3/23: FCD:03/03/2023->/23; 8/6/23: 90%->100 / Impacted TSs and TRs: 23.501; 23.502; 23.402
- 619: 13/7/22: 33.858 added;; 12/9/22: 0%->10; 11/12/22: 10%->60; 17/3/23: 60%->78; 8/6/23: 78%->99; 15/3/24: 99%->100 / Impacted TSs and TRs: 33.858
- 620: ; 8/6/23: 0%->65; 7/9/23: 65%->90; 14/3/24: 90%->100 / Impacted TSs and TRs: 33.501
- 621: ; 6/6/23: Compl:33%->60%; 30/6/23: WID:CP-223104->CP-231286 / Impacted TSs and TRs: 23.122; 24.229; 24.302; 24.501; 24.502; 24.526; 29.507; 29.512; 29.513; 29.525; 23.003; 29.518; 29.503; 29.550
- 622: ; 9/6/23: 30%->60 / Impacted TSs and TRs: 23.122; 24.229; 24.302; 24.501; 24.502; 24.526; 29.507; 29.512; 29.513; 29.525; 23.003; 29.518; 29.503; 29.550
- 623: ; 6/6/23: Compl:50%->65% / Impacted TSs and TRs: 23.122; 24.229; 24.302; 24.501; 24.502; 24.526; 29.507; 29.512; 29.513; 29.525; 23.003; 29.518; 29.503; 29.550
- 624: 7/1/22: 28.828 added;; 12/9/22: 0%->60; 11/12/22: 60%->75; 17/3/23: 75%->100 / Impacted TSs and TRs: 28.828
- 625: ; 8/6/23: 0%->10; 7/9/23: 10%->30; 8/12/23: 30%->65; 14/3/24: 65%->100 / Impacted TSs and TRs: 32.255; 32.256; 28.203; 32.291; 32.298
- 626: ; 7/6/23: Compl:0%->97%; 6/9/23: FCD:09/09/2023->22/09/2023; Compl:97%->100%; WID: RP-230788->RP-231185; Stat Rep: ->RP-232261; Rapporteur: China Telecom->Shengnan Liu, China Telecom; Rap eMail: ->liushn@chinatelecom.cn; ; 21/9/23: FCD:22/09/2023->12/1...; 2/1/24: WID:RP-231185->RP-233569
- 627: -
- 628: 26/6/19: 23.760 added; 21/01/22: moved Rel-17 to Rel-18 at SA#94e. Deletion of 940072, temporarily mistakenly added as FS_eUEPO_Ph2; WID:SP-190449->SP-211649; 12/3/22: 0%->25; 4/6/22: 25%->70; 4/6/22: FCD:12/09/2022->12/22; 12/9/22: 70%->80; 10/12/22: ...; 15/3/23: 95%->100 / Impacted TSs and TRs: New ; 23.760
- 629: Impacted TSs and TRs: 23.501; 23.502; 23.503
- 630: ; 9/1/23: WID:SP-220980->SP-221342; 15/3/23: 0%->65; 15/3/23: WID:SP-221342->SP-230094; 15/3/23: FCD:03/03/2023->/23; 8/6/23: 65%->100 / Impacted TSs and TRs: 23.501; 23.502; 23.503
- 631: ; 6/6/23: Compl:10%->30%; 6/6/23: WID: CP-230276->CP-231192 / Impacted TSs and TRs: 24.008.24.301.24.501.24.526.29.512.29.513.29.519.29.520.29.522.29.525.29.244.29.564
- 632: ; 6/6/23: Compl:10%->40%; 6/6/23: WID: CP-230276->CP-231192 / Impacted TSs and TRs: 24.008.24.301.24.501.24.526.29.512.29.513.29.519.29.520.29.522.29.525.29.244.29.564
- 633: ; 6/6/23: Compl:10%->30%; 6/6/23: WID: CP-230276->CP-231192 / Impacted TSs and TRs: 24.008.24.301.24.501.24.526.29.512.29.513.29.519.29.520.29.522.29.525.29.244.29.564
- 634: ; 22/3/23: 0%->80; 22/3/23: FCD:12/12/2022->06/20 / Impacted TSs and TRs: 23.503; 23.501; 23.502
- 635: ; 22/3/23: 0%->80; 22/3/23: FCD:12/12/2022->06/20; 8/6/23: 80%->100 / Impacted TSs and TRs: 23.503; 23.501; 23.502
- 636: Impacted TSs and TRs: 29.513; 29.519; 29.594
- 637: Impacted TSs and TRs: 29.513; 29.519; 29.594

| ID | WBS | Task | Type | Duration | Start | Finish | Complete | Remaining | Actual finish | Total slack | Constraint | Resources | Work | Actual work | Acronym | PCG approved | Impacted TSs and TRs | WI rapporteur name | WI rapporteur e-mail | Release | TSG approved |
| --- | --- | --- | --- | --- | --- | --- | --- | --- | --- | --- | --- | --- | --- | --- | --- | --- | --- | --- | --- | --- | --- |
| 638 | 332 | **Rel-18 Enhancements of UE Policy** |  | 1247d | 2019-03-07 A | 2023-12-13 | 100% |  | 2023-12-12 |  |  |  | 19920h | 19920h | UEP18 | 49 | 29.525; 29.507; 29.513; 29.518 | Fuencisla García, Ericsson | fuencisla.garcia@ericsson.com | Rel-18 | 97 |
| 639 | 332.1 | CT3 aspects of UEP18 |  | 1246d | 2019-03-07 A | 2023-12-12 A | 100% |  |  |  | finish no earlier than 2023-12-12 | C3 | 9968h | 9968h | UEP18 | 49 | 29.525; 29.507; 29.513 | Fuencisla García, Ericsson | fuencisla.garcia@ericsson.com | Rel-18 | 97 |
| 640 | 332.2 | CT4 aspects of UEP18 |  | 1244d | 2019-03-11 A | 2023-12-12 A | 100% |  |  |  | finish no earlier than 2023-12-12 | C4 | 9952h | 9952h | UEP18 | 49 | 29.518 | Fuencisla García, Ericsson | fuencisla.garcia@ericsson.com | Rel-18 | 97 |
| 641 | 333 | **5G AM Policy** |  | 1304d | 2019-03-07 A | 2024-03-03 A | 100% |  |  |  |  |  | 5640h | 5640h | AMP | 49 | 23.501; 23.502; 23.503 | Chen, Zhuoyi, China Telecom | chenzy34@chinatelecom.cn | Rel-18 | 97 |
| 642 | 333.1 | Study on 5G AM Policy |  | 191d | 2021-12-20 A | 2022-09-12 A | 100% |  |  |  | finish no earlier than 2022-09-12 | S2 | 1528h | 1528h | FS_AMP | 48 | 23.700-89 | Chen, Zhuoyi, China Telecom | chenzy34@chinatelecom.cn | Rel-18 | 94 |
| 643 | 333.2 | Stage 2 of 5G AM Policy | milestone | 0d | 2019-03-07 A | 2019-03-07 A | 100% |  |  |  | finish no earlier than 2023-03-03 | S2 |  |  | AMP | 49 | 23.501; 23.502; 23.503 | Chen, Zhuoyi, China Telecom | chenzy34@chinatelecom.cn | Rel-18 | 97 |
| 644 | 333.3 | CT3 aspects of 5G AM Policy |  | 257d | 2023-03-13 A | 2024-03-03 A | 100% |  |  |  | finish no earlier than 2024-03-03 | C3 | 2056h | 2056h | AMP | 49 | 29.507; 29.513; 29.274 | SUN, Yue, China Telecom | suny20@chinatelecom.cn | Rel-18 | 97 |
| 645 | 333.4 | CT4 aspects of 5G AM Policy |  | 257d | 2023-03-13 A | 2024-03-03 A | 100% |  |  |  | finish no earlier than 2024-03-03 | C4 | 2056h | 2056h | AMP | 49 | 29.507; 29.513; 29.274 | SUN, Yue, China Telecom | suny20@chinatelecom.cn | Rel-18 | 97 |
| 646 | 334 | **Dynamically Changing AM Policies in the 5GC Phase 2** |  | 451d | 2021-12-20 A | 2023-09-09 A | 100% |  |  |  |  |  | 10272h | 10272h | TEI18_DCAMP_Ph2 | 49 | 23.502 | Yubing Liu | liuyb9@chinatelecom.cn | Rel-18 | 97 |
| 647 | 334.1 | Stage 2 of TEI18_DCAMP_Ph2 |  | 382d | 2021-12-20 A | 2023-06-06 A | 100% |  |  |  | finish no earlier than 2023-06-06 | S2 | 3056h | 3056h | TEI18_DCAMP_Ph2 | 49 | 23.502 | Yubing Liu | liuyb9@chinatelecom.cn | Rel-18 | 97 |
| 648 | 334.2 | CT3 aspects on Dynamically Changing AM Policies in the 5GC Phase 2 |  | 451d | 2021-12-20 A | 2023-09-09 A | 100% |  |  |  | finish no earlier than 2023-09-09 | C3 | 3608h | 3608h | TEI18_DCAMP_Ph2 | 49 | 29.513; 29.519; 29.522; 29.534 | SUN, Yue, China Telecom | suny20@chinatelecom.cn | Rel-18 | 97 |
| 649 | 334.3 | CT4 aspects on Dynamically Changing AM Policies in the 5GC Phase 2 |  | 451d | 2021-12-20 A | 2023-09-09 A | 100% |  |  |  | finish no earlier than 2023-09-09 | C4 | 3608h | 3608h | TEI18_DCAMP_Ph2 | 49 | 29.513; 29.519; 29.522; 29.534 | SUN, Yue, China Telecom | suny20@chinatelecom.cn | Rel-18 | 97 |
| 650 | 335 | Rel-18 User plane improvements | milestone | 0d? | 2016-03-15 A | 2016-03-15 A | 100% |  |  |  | start no earlier than 2016-03-15 |  |  |  |  |  |  |  |  | Rel-18 |  |
| 651 | 336 | Study on Film Grain Synthesis |  | 456d | 2023-06-08 A | 2025-03-03 | 30% | 319.2d |  | 261d | finish no earlier than 2025-03-03 | S4 | 3648h |  | FS_FGS | 51 | 26.955 | Brian Lee (Dolby Laboratories) | Brian.Lee@dolby.com | Rel-19 | 100 |
| 652 | 337 | Study on new HEVC profiles and operating points |  | 194d | 2023-06-08 A | 2024-03-03 A | 100% |  |  |  | start no earlier than 2023-06-08 | S4 | 1552h | 1552h | FS_HEVC_Profiles | 51 | 26.955 ; 26.966 | Waqar Zia | waqar_zia (at) apple.com | Rel-18 | 100 |
| 653 | 338 | Study of Avatars in Real-Time Communication Services |  | 399d | 2023-06-08 A | 2024-12-12 | 30% | 279.3d |  | 318d | finish no earlier than 2024-12-12 | S4 | 3192h |  | FS_AVATAR | 51 | 26.813 | Bouazizi, Imed, Qualcomm Incorporated | bouazizi AT qti DOT qualcomm DOT com | Rel-19 | 100 |
| 654 | 339 | Study on 5G Media Service Enablers |  | 261d | 2021-12-13 A | 2022-12-12 A | 100% |  |  |  | finish no earlier than 2022-12-12 | S4 | 2088h | 2088h | FS_5G_MSE | 48 |  | Thomas Stockhammer, Qualcomm Incorporated | tsto@qti.qualcomm.com | Rel-18 | 94 |
| 655 | 340 | UE Testing Phase 2 |  | 459d | 2022-06-02 A | 2024-03-03 A | 100% |  |  |  | finish no earlier than 2024-03-03 | S4 | 3672h | 3672h | eUET | 49 | 26.131; 26.132; 26.801 ; 26.130 | Stéphane Ragot, Orange | stephane.ragot@orange.com | Rel-18 | 96 |
| 656 | 341 | 5G Media Streaming Audio codec phase 2 for 5G-Advanced |  | 61d | 2022-12-09 A | 2023-03-03 A | 100% |  |  |  | finish no earlier than 2023-03-03 | S4 | 488h | 488h | 5GMS_Audio_Ph2 | 50 | 26.117; 26.511 | Frédéric Gabin (Dolby Laboratories Inc.) | frederic.gabin@dolby.com | Rel-18 | 98 |
| 657 | 342 | 5G Media Streaming Architecture Phase 2 |  | 264d | 2022-06-02 A | 2023-06-06 A | 100% |  |  |  | finish no earlier than 2023-06-06 | S4 | 2112h | 2112h | 5GMS_Ph2 | 49 | 26.501 | Iraj Sodagar, Tencent | <irajs@live.com> | Rel-18 | 96 |
| 658 | 343 | Enhanced Multiparty RTT |  | 322d | 2022-12-12 A | 2024-03-03 A | 100% |  |  |  | finish no earlier than 2024-03-03 | S4 | 2576h | 2576h | MP_RTT | 50 | 26.114 ; 26.982 | Huan-yu Su, Huawei | su.huanyu@huawei.com | Rel-18 | 98 |
| 659 | 344 | Traffic Models and Quality Evaluation Methods for Media and XR Services in 5G Systems |  | 905d | 2020-03-25 A | 2023-09-09 A | 100% |  |  |  | finish no earlier than 2023-09-09 | S4 | 7240h | 7240h | FS_XRTraffic | 44 | 26.925 | Thomas Stockhammer | tsto@qti.qualcomm.com | Rel-18 | 87 |
| 660 | 345 | 5G-Advanced media profiles for messaging services |  | 194d | 2023-06-08 A | 2024-03-03 A | 100% |  |  |  | finish no earlier than 2024-03-03 | S4 | 1552h | 1552h | PROMISE | 51 | 26.140; 26.141 ; 26.143 | Frédéric Gabin (Dolby Laboratories Inc.) – | frederic.gabin@dolby.com | Rel-18 | 100 |
| 661 | 346 | 5G Media Streaming Protocols Phase 2 |  | 264d | 2023-06-08 A | 2024-06-06 | 75% | 66d |  | 453d | finish no earlier than 2024-06-06 | S4 | 2112h |  | 5GMS_Pro_Ph2 | 51 | 26.512; 26.247; 26.517; 26.532 ; 26.510 | Thomas Stockhammer, Qualcomm Incorporated, | tsto@qti.qualcomm.com | Rel-18 | 100 |
| 662 | 347 | Rel-18 Other topics | milestone | 0d? | 2016-03-15 A | 2016-03-15 A | 100% |  |  |  | start no earlier than 2016-03-15 |  |  |  |  |  |  |  |  | Rel-18 |  |

Notes:
- 639: ; 6/6/23: Compl:20%->50%
- 641: ; 10/12/22: 0%->80; 9/1/23: WID:SP-220807->SP-221335
- 642: 21/1/22: 23.700-89 added;; 4/6/22: 0%->80; 21/6/22: WID:SP-211642->SP-220647; 12/9/22: 80%->100
- 643: ; 10/12/22: 0%->80; 9/1/23: WID:SP-220807->SP-221335; 15/3/23: 80%->100;
- 644: ; 6/6/23: Compl:0%->85%; 6/6/23: CD:16/06/2023->09/09/2023; 6/6/23: WID: CP-230116->CP-231302
- 645: ; 6/6/23: Compl:0%->90%; 6/6/23: WID: CP-230116->CP-231302
- 647: ; 16/3/23: FCD:12/09/2022->/23; 16/3/23: WID:SP-220799->SP-230102
- 648: ; 6/6/23: Compl:0%->80%; 6/6/23: CD:12/09/2022->09/09/2023
- 649: ; 6/6/23: Compl:0%->80%; 6/6/23: CD:12/09/2022->09/09/2023
- 650: -
- 651: ; 7/9/23: 0%->10; 8/12/23: 10%->20; 8/12/23: FCD:12/12/2023->/2024; 14/3/24: 20%->30; 14/3/24: FCD:03/03/2024->3/3/25; Rel-18->Rel-19
- 652: ; 7/9/23: 0%->30; 21/9/23: 26.966 added;; 8/12/23: 30%->65; 14/3/24: 65%->100
- 653: 7/9/23: 0%->5; 21/9/23: 26.813 added;; 8/12/23: 5%->20; 14/3/24: 20%->30; 14/3/24: FCD:03/03/2024->12/24; ; Rel-18->Rel-19
- 654: 12/3/22: 0%->20; 4/6/22: 20%->30; 12/9/22: 30%->60; 12/9/22: FCD:12/09/2022->12/22; 11/12/22: 60%->100
- 655: ; 3/8/22: 26.130 added; 17/8/22: UETest_Ph2-> eUET; 12/9/22: 0%->10; 11/12/22: 10%->15; 17/3/23: 15%->20; 8/6/23: 20%->30; 7/9/23: 30%->35; 7/9/23: FCD:12/12/2023->/24; 8/12/23: 35%->65; 14/3/24: 65%->100
- 656: 17/3/23: 0%->100
- 657: 17/8/22: 5GMSA_Ph2-> 5GMS_Ph2; 17/8/22: WID:SP-220614->SP-220667; 12/9/22: 0%->15; 11/12/22: 15%->25; 16/3/23: WID:SP-220667->SP-230164; 16/3/23: FCD:03/03/2023->/23; 17/3/23: 25%->50; 8/6/23: 50%->100
- 658: ; 17/3/23: 0%->5; 8/6/23: 5%->30; 7/9/23: 30%->50; 8/12/23: 50%->75; 8/12/23: FCD:12/12/2023->/2024; 8/12/23: WID:SP-221346->SP-231290; 3/1/24: WID:SP-231290->SP-231709; 14/3/24: 75%->100; 3/4/24: 26.982 added;
- 659: 10/6/20: 0%->15; 28/06/20: Rel-16->Rel-17; 5/12/20: 15%->40; 21/3/21: 40%->50; 21/3/21: FCD:18/06/2020->09/21; 11/6/21: 50%->65. 2/7/21: name change from "Study on Typical Traffic Characteristics for XR Services and other Media"; 13/9/21: 65%->70; 13/1...; 7/9/23: 95%->100
- 660: 30/6/23: 26.143 added;; 7/9/23: 0%->15; 8/12/23: 15%->40; 14/3/24: 40%->100
- 661: ; 7/9/23: WID:SP-230543->SP-230976; 7/9/23: 0%->25; ; 21/9/23: 26.510 added;; 8/12/23: 25%->55; 14/3/24: 55%->75; 14/3/24: FCD:03/03/2024->/24
- 662: -

| ID | WBS | Task | Duration | Start | Finish | Complete | Remaining | Total slack | Constraint | Resources | Work | Actual work | Acronym | PCG approved | WI rapporteur name | WI rapporteur e-mail | Release | TSG approved |
| --- | --- | --- | --- | --- | --- | --- | --- | --- | --- | --- | --- | --- | --- | --- | --- | --- | --- | --- |
| 663 | 348 | **Support for Wireless and Wireline Convergence Phase 2** | 577d? | 2021-12-20 A | 2024-03-03 A | 100% |  |  |  |  | 16384h | 16384h | 5WWC_Ph2 | 49 | Laurent Thiebaut, Nokia | Laurent.thiebaut@nokia.com | Rel-18 | 97 |
| 664 | 348.1 | Study on the support for 5WWC Phase 2 | 256d? | 2021-12-20 A | 2022-12-12 A | 100% |  |  | finish no earlier than 2022-12-12 | S2 | 2048h | 2048h | FS_5WWC_Ph2 | 43 | Laurent Thiebaut, Nokia | laurent.thiebaut@nokia.com | Rel-18 | 84 |
| 665 | 348.2 | Study on Security aspects for 5WWC Phase 2 | 197d | 2022-06-02 A | 2023-03-03 A | 100% |  |  | finish no earlier than 2023-03-03 | S3 | 1576h | 1576h | FS_5WWC_Ph2_Sec | 49 | Saurabh Khare, Nokia | Saurabh.khare@nokia.com | Rel-18 | 96 |
| 666 | 348.3 | Stage 2 of 5WWC_Ph2 | 382d | 2021-12-20 A | 2023-06-06 A | 100% |  |  | finish no earlier than 2023-06-06 | S2 | 3056h | 3056h | 5WWC_Ph2 | 49 | Laurent Thiebaut, Nokia | Laurent.thiebaut@nokia.com | Rel-18 | 97 |
| 667 | 348.4 | CT1 aspects of 5WWC_Ph2 | 318d | 2022-12-16 A | 2024-03-03 A | 100% |  |  | finish no earlier than 2024-03-03 | C1 | 2544h | 2544h | 5WWC_Ph2 | 49 | Nassar, Mohamed A.(Nokia) | mohamed.a.nassar@nokia.com | Rel-18 | 97 |
| 668 | 348.5 | CT3 aspects of 5WWC_Ph2 | 318d | 2022-12-16 A | 2024-03-03 A | 100% |  |  | finish no earlier than 2024-03-03 | C3 | 2544h | 2544h | 5WWC_Ph2 | 49 | Nassar, Mohamed A.(Nokia) | mohamed.a.nassar@nokia.com | Rel-18 | 97 |
| 669 | 348.6 | CT4 aspects of 5WWC_Ph2 | 319d | 2022-12-15 A | 2024-03-03 A | 100% |  |  | finish no earlier than 2024-03-03 | C4 | 2552h | 2552h | 5WWC_Ph2 | 49 | Nassar, Mohamed A.(Nokia) | mohamed.a.nassar@nokia.com | Rel-18 | 97 |
| 670 | 348.7 | Security aspects for 5WWC Phase 2 | 128d | 2023-03-16 A | 2023-09-09 A | 100% |  |  | finish no earlier than 2023-09-09 | S3 | 1024h | 1024h | 5WWC_Ph2_Sec | 50 | Khare, Saurabh, Nokia | saurabh.khare@nokia.com | Rel-18 | 99 |
| 671 | 348.8 | Charging Aspects of 5WWC phase 2 | 130d | 2023-09-06 A | 2024-03-03 A | 100% |  |  | finish no earlier than 2024-03-03 | S5 | 1040h | 1040h | 5WWC_Ph2 | 51 | Sun Mingrui, China Unicom | sunmr19@chinaunicom.cn | Rel-18 | 101 |
| 672 | 349 | **Enhancement of NSAC for maximum number of UEs with at least one PDU session/PDN connection** | 329d | 2022-09-09 A | 2023-12-12 A | 100% |  |  |  |  | 4616h | 4616h | eNSAC | 49 | ZHU Jinguo, ZTE | zhu.jinguo@zte.com.cn | Rel-18 | 97 |
| 673 | 349.1 | Stage 2 of eNSAC | 193d | 2022-09-09 A | 2023-06-06 A | 100% |  |  | finish no earlier than 2023-06-06 | S2 | 1544h | 1544h | eNSAC | 49 | ZHU Jinguo, ZTE | zhu.jinguo@zte.com.cn | Rel-18 | 97 |
| 674 | 349.2 | CT3 aspects of eNSAC | 124d | 2022-12-15 A | 2023-06-06 A | 100% |  |  | finish no earlier than 2023-06-06 | C3 | 992h | 992h | eNSAC | 49 | Li, Zhijun, ZTE | li.zhijun3@zte.com.cn | Rel-18 | 97 |
| 675 | 349.3 | CT4 aspects of eNSAC | 260d | 2022-12-15 A | 2023-12-12 A | 100% |  |  | finish no earlier than 2023-12-12 | C4 | 2080h | 2080h | eNSAC | 49 | Li, Zhijun, ZTE | li.zhijun3@zte.com.cn | Rel-18 | 97 |
| 676 | 350 | Management Data Analytics phase 2 | 378d | 2022-09-23 A | 2024-03-03 A | 100% |  |  | finish no earlier than 2024-03-03 | S5 | 3024h | 3024h | eMDAS_Ph2 | 49 | Yao, Yizhi, Intel | yizhi<dot>yao<at>intel<dot>com | Rel-18 | 97 |
| 677 | 351 | **Application Data Analytics Enablement Service** | 582d | 2021-12-13 A | 2024-03-03 | 88% | 67.83d | 523d |  |  | 9296h | 3104h | ADAES | 49 | Pateromichelakis, Emmanouil (Manos) | epateromiche@lenovo.com | Rel-18 | 97 |
| 678 | 351.1 | Study on Application Data Analytics Enablement Service | 196d | 2021-12-13 A | 2022-09-12 A | 100% |  |  | finish no earlier than 2022-09-12 | S6 | 1568h | 1568h | FS_ADAES | 48 | Pateromichelakis, Emmanouil (Manos) | epateromiche@lenovo.com | Rel-18 | 94 |
| 679 | 351.2 | Stage 2 of ADAES | 192d | 2022-09-12 A | 2023-06-06 A | 100% |  |  | finish no earlier than 2023-06-06 | S6 | 1536h | 1536h | ADAES | 49 | Pateromichelakis, Emmanouil (Manos) | epateromiche@lenovo.com | Rel-18 | 97 |
| 680 | 351.3 | CT1 aspects of ADAES | 387d | 2022-09-12 A | 2024-03-03 | 95% | 19.35d | 523d | finish no earlier than 2024-03-03 | C1 | 3096h |  | ADAES | 49 | Atarius, Roozbeh, Lenovo | ratarius@motorola.com | Rel-18 | 97 |
| 681 | 351.4 | CT3 aspects of ADAES | 387d | 2022-09-12 A | 2024-03-03 | 70% | 116.1d | 523d | finish no earlier than 2024-03-03 | C3 | 3096h |  | ADAES | 49 | Atarius, Roozbeh, Lenovo | ratarius@motorola.com | Rel-18 | 97 |
| 682 | 352 | Study on Seamless UE context recovery | 191d | 2021-12-20 A | 2022-09-12 A | 100% |  |  | finish no earlier than 2022-09-12 | S2 | 1528h | 1528h | FS_SUECR | 48 | Lalith Kumar | lalith.kumar@samsung.com | Rel-18 | 94 |
| 683 | 353 | **Seamless UE context recovery** | 263d | 2022-09-08 A | 2023-09-09 A | 100% |  |  |  |  | 5152h | 5152h | SUECR | 49 | Lalith kumar, Samsung | lalith.kumar@samsung.com | Rel-18 | 97 |
| 684 | 353.1 | Stage 2 of Seamless UE context recovery | 68d | 2022-09-08 A | 2022-12-12 A | 100% |  |  | finish no earlier than 2022-12-12 | S2 | 544h | 544h | SUECR | 49 | Lalith kumar, Samsung | lalith.kumar@samsung.com | Rel-18 | 97 |
| 685 | 353.2 | CT1 aspects of Seamless UE context recovery | 192d | 2022-12-16 A | 2023-09-09 A | 100% |  |  | finish no earlier than 2023-09-09 | C1 | 1536h | 1536h | SUECR | 49 | Hashmi, Danish Ehsan, Samsung | danis.hashmi@samsung.com | Rel-18 | 97 |
| 686 | 353.3 | CT3 aspects of Seamless UE context recovery | 192d | 2022-12-16 A | 2023-09-09 A | 100% |  |  | finish no earlier than 2023-09-09 | C3 | 1536h | 1536h | SUECR | 49 | Hashmi, Danish Ehsan, Samsung | danis.hashmi@samsung.com | Rel-18 | 97 |
| 687 | 353.4 | CT4 aspects of Seamless UE context recovery | 192d | 2022-12-16 A | 2023-09-09 A | 100% |  |  | finish no earlier than 2023-09-09 | C4 | 1536h | 1536h | SUECR | 49 | Hashmi, Danish Ehsan, Samsung | danis.hashmi@samsung.com | Rel-18 | 97 |

Notes:
- 663: Impacted TSs and TRs: 23.501; 23.502; 23.503
- 664: 26/6/19: 23.700-16 added; 21/01/22: moved Rel-17 to Rel-18 at SA#94e. Deletion of 940062, temporarily mistakenly added as FS_5WWV_Ph3; WID:SP-190562->SP-211640; 12/3/22: 0%->30. 4/6/22: 30%->60; 21/6/22: WID:SP-211640...; 12/9/22: FCD:12/09/2022->12/20...; 15/3/23: 90%->100 / Impacted TSs and TRs: 23.700-17
- 665: 13/7/22: 33.887 added;; 12/9/22: 0%->30; 11/12/22: 30%->60; 9/1/23: WID:SP-220528->SP-221144; 17/3/23: 60%->80; 8/6/23: 80%->100 / Impacted TSs and TRs: 33.887
- 666: ; 15/3/23: 30%->45; 15/3/23: WID:SP-220904->SP-230100; 15/3/23: FCD:12/12/2022->/23; 31/3/23: WID:SP-230100->SP-230367; 8/6/23: 45%->100 / Impacted TSs and TRs: 23.501; 23.502; 23.503
- 667: ; 6/6/23: Compl:50%->60%; 30/6/23: WID:CP-223114->CP-231302; 30/6/23: WID:CP-231302->CP-231287 / Impacted TSs and TRs: 24.501; 24.502; 24.526; 29.513; 29.525; 23.003; 29.522
- 668: ; 9/6/23: 15%->40 / Impacted TSs and TRs: 24.501; 24.502; 24.526; 29.513; 29.525; 23.003; 29.522
- 669: ; 6/6/23: Compl:40%->65% / Impacted TSs and TRs: 24.501; 24.502; 24.526; 29.513; 29.525; 23.003; 29.522
- 670: ; 8/6/23: 0%->80; 15/3/24: 80%->100 / Impacted TSs and TRs: 33.501
- 671: ; 8/12/23: 0%->40; 14/3/24: 40%->100 / Impacted TSs and TRs: 32.255; 32.291; 32.298
- 672: Impacted TSs and TRs: 23.501; 23.502
- 673: ; 16/3/23: FCD:03/03/2023->/23; 16/3/23: WID:SP-220988->SP-230113; 8/6/23: 0%->100 / Impacted TSs and TRs: 23.501; 23.502
- 674: Impacted TSs and TRs: 29.510; 29.536; 29.571; 29.122; 29.522
- 675: ; 6/6/23: Compl:0%->25% / Impacted TSs and TRs: 29.510; 29.536; 29.571; 29.122; 29.522
- 676: ; 11/12/22: 0%->5; 17/3/23: 5%->15; 8/6/23: 15%->25; 8/6/23: 25%->25; 7/9/23: 25%->50; 8/12/23: 50%->87; 8/12/23: FCD:12/12/2023->/2024; 14/3/24: 87%->100; 2/4/24: WID:SP-220981->SP-240267 / Impacted TSs and TRs: 28.104; 28.552; 32.425; 28.554; 28.541; 28.622; 28.623; 28.533
- 677: ; 23/9/22: 23.436 added;; 11/12/22: 0%->45; 11/12/22: 45%-> / Impacted TSs and TRs: 23.434 ; 23.436
- 678: 7/1/22: 23.700-36 added;; 12/3/22: 0%->15; 4/6/22: 15%->55; 12/9/22: 55%->95; 11/12/22: 95%->100 / Impacted TSs and TRs: 23.700-36
- 679: ; 23/9/22: 23.436 added;; 11/12/22: 0%->45; 11/12/22: 45%->; 17/3/23: FCD:03/03/2023->/23; 17/3/23: WID:SP-220913->SP-230275; 17/3/23: 45%->80; 8/6/23: 80%->100 / Impacted TSs and TRs: 23.434 ; 23.436
- 680: 31/3/23: 24.559 added;; 6/6/23: Compl:0%->5% / Impacted TSs and TRs: 29.549; 24.559
- 681: 9/6/23: 0%->5 / Impacted TSs and TRs: 29.549
- 682: 21/1/22: 23.700-61 added;; 12/3/22: 0%->25; 4/6/22: 25%->100 / Impacted TSs and TRs: 23.700-61
- 683: Impacted TSs and TRs: 23.501; 23.502
- 684: ; 10/12/22: 0%->100 / Impacted TSs and TRs: 23.501; 23.502
- 685: ; 6/6/23: Compl:90%->95% / Impacted TSs and TRs: 24.501; 27.007; 29.122; 29.522; 29.518
- 686: ; 9/6/23: 60%->80 / Impacted TSs and TRs: 24.501; 27.007; 29.122; 29.522; 29.518
- 687: Impacted TSs and TRs: 24.501; 27.007; 29.122; 29.522; 29.518

| ID | WBS | Task | Duration | Start | Finish | Complete | Remaining | Total slack | Constraint | Resources | Work | Actual work | Acronym | PCG approved | Impacted TSs and TRs | WI rapporteur name | WI rapporteur e-mail | Release | TSG approved |
| --- | --- | --- | --- | --- | --- | --- | --- | --- | --- | --- | --- | --- | --- | --- | --- | --- | --- | --- | --- |
| 688 | 354 | **5G System Enabler for Service Function Chaining** | 577d | 2021-12-20 A | 2024-03-03 A | 100% |  |  |  |  | 10280h | 10280h | SFC | 49 | 23.501; 23.502; 23.503 | Meghashree Dattatri Kedalagudde, Intel | meghashree.dattatri.kedalagudde@intel.com | Rel-18 | 97 |
| 689 | 354.1 | Stage 2 of 5G System Enabler for Service Function Chaining | 193d | 2022-09-09 A | 2023-06-06 A | 100% |  |  | finish no earlier than 2023-06-06 | S2 | 1544h | 1544h | SFC | 49 | 23.501; 23.502; 23.503 | Meghashree Dattatri Kedalagudde, Intel | meghashree.dattatri.kedalagudde@intel.com | Rel-18 | 97 |
| 690 | 354.2 | CT3 aspects of SFC | 318d | 2022-12-16 A | 2024-03-03 A | 100% |  |  | finish no earlier than 2024-03-03 | C3 | 2544h | 2544h | SFC | 49 | 29.244; 29.512; 29.513; 29.514; 29.519; 29.522 | Yue Sun, China Telecom | suny20@chinatelecom.cn | Rel-18 | 97 |
| 691 | 354.3 | CT4 aspects of SFC | 518d | 2021-12-20 A | 2023-12-12 A | 100% |  |  | finish no earlier than 2023-12-12 | C4 | 4144h | 4144h | SFC | 49 | 29.244; 29.512; 29.513; 29.514; 29.519; 29.522 | Yue Sun, China Telecom | suny20@chinatelecom.cn | Rel-18 | 97 |
| 692 | 354.4 | Study on System Enabler for Service Function Chaining | 256d | 2021-12-20 A | 2022-12-12 A | 100% |  |  | finish no earlier than 2022-12-12 | S2 | 2048h | 2048h | FS_SFC | 48 | 23.700-18 | Meghashree D Kedalagudde, Intel | meghashree.dattatri.kedalagudde@intel.com | Rel-18 | 94 |
| 693 | 355 | Study on Extensions to the TSC Framework to support Deterministic Networking (DetNet) | 256d | 2021-12-20 A | 2022-12-12 A | 100% |  |  | finish no earlier than 2022-12-12 | S2 | 2048h | 2048h | FS_DetNet | 48 | 23.700-46 | Miklós, György, Ericsson | gyorgy.miklos@ericsson.com | Rel-18 | 94 |
| 694 | 356 | **Extensions to the TSC Framework to support DetNet** | 389d | 2022-09-08 A | 2024-03-03 | 77% | 90.07d | 0d |  |  | 10784h | 8876h | DetNet | 49 | 23.501; 23.502; 23.503 | Miklós, György, Ericsson | gyorgy.miklos@ericsson.com | Rel-18 | 97 |
| 695 | 356.1 | Stage 2 of Extensions to the TSC Framework to support DetNet | 194d | 2022-09-08 A | 2023-06-06 A | 100% |  |  | finish no earlier than 2023-06-06 | S2 | 1552h | 1552h | DetNet | 49 | 23.501; 23.502; 23.503 | Miklós, György, Ericsson | gyorgy.miklos@ericsson.com | Rel-18 | 97 |
| 696 | 356.2 | CT1 aspects of Detnet | 259d | 2022-12-16 A | 2023-12-12 A | 100% |  |  | finish no earlier than 2023-12-12 | C1 | 2072h | 2072h | DetNet | 49 | 24.539; 29.244; 29.513; 29.512; 29.514 | Fuencisla García, Ericsson | fuencisla.garcia@ericsson.com | Rel-18 | 97 |
| 697 | 356.3 | **CT3 aspects of Detnet** | 318d | 2022-12-16 A | 2024-03-03 | 25% | 238.5d | 0d |  | C3 | 5088h | 3180h | DetNet | 49 | 24.539; 29.244; 29.513; 29.512; 29.514 | Fuencisla García, Ericsson | fuencisla.garcia@ericsson.com | Rel-18 | 97 |
| 698 | 356.3.1 | (IETF) CT3 part of DetNet (draft-ietf-detnet-yang) | 318d | 2022-12-16 A | 2024-03-03 | 25% | 238.5d | 0d | finish no earlier than 2024-03-03 | C3-IETF | 2544h | 2544h | DetNet | 49 | 29.513, 29.565 | Fuencisla García, Ericsson | fuencisla.garcia@ericsson.com | Rel-18 | 97 |
| 699 | 356.4 | CT4 aspects of Detnet | 259d | 2022-12-16 A | 2023-12-12 A | 100% |  |  | finish no earlier than 2023-12-12 | C4 | 2072h | 2072h | DetNet | 49 | 24.539; 29.244; 29.513; 29.512; 29.514 | Fuencisla García, Ericsson | fuencisla.garcia@ericsson.com | Rel-18 | 97 |
| 700 | 357 | **Multiple location report for MT-LR Immediate Location Request for regulatory services** | 194d | 2022-09-08 A | 2023-06-06 A | 100% |  |  |  |  | 1528h | 1528h | TEI18_MLR | 49 | 23.273 | Joul, Christopher, T-Mobile USA | chris.joul@t-mobile.com | Rel-18 | 97 |
| 701 | 357.1 | Stage 2 of TEI18_MLR | 68d | 2022-09-08 A | 2022-12-12 A | 100% |  |  | finish no earlier than 2022-12-12 | S2 | 544h | 544h | TEI18_MLR | 49 | 23.273 | Joul, Christopher, T-Mobile USA | chris.joul@t-mobile.com | Rel-18 | 97 |
| 702 | 357.2 | CT4 aspects on TEI18_MLR | 123d | 2022-12-16 A | 2023-06-06 A | 100% |  |  | finish no earlier than 2023-12-12 | C4 | 984h | 984h | TEI18_MLR | 49 | 29.571; 29.518 | Jones Yunjie, Lu, Ericsson | jones.lu@ericsson.com | Rel-18 | 97 |
| 703 | 358 | **TEI18 on Enhancement of Application Detection Event Exposure** | 194d | 2022-09-08 A | 2023-06-06 A | 100% |  |  |  |  | 2008h | 2008h | TEI18_ADEE | 49 | 23.503; 23.502 | Aihua Li, China Mobile | liaihua@chinamobile.com | Rel-18 | 97 |
| 704 | 358.1 | Stage 2 of TEI18_ADEE | 127d | 2022-09-08 A | 2023-03-03 A | 100% |  |  | finish no earlier than 2023-03-03 | S2 | 1016h | 1016h | TEI18_ADEE | 49 | 23.503; 23.502 | Aihua Li, China Mobile | liaihua@chinamobile.com | Rel-18 | 97 |
| 705 | 358.2 | CT3 aspects of TEI18_ADEE | 124d | 2022-12-15 A | 2023-06-06 A | 100% |  |  | finish no earlier than 2023-06-06 | C3 | 992h | 992h | TEI18_ADEE | 49 | 29.522; 29.514; 29.512 | Zhenning Huang, China Mobile | huangzhenning@chinamobile.com | Rel-18 | 97 |
| 706 | 359 | **General Support of IPv6 Prefix Delegation in 5GS** | 330d | 2022-09-08 A | 2023-12-12 A | 100% |  |  |  |  | 7232h | 7232h | TEI18_IPv6PD | 49 | 23.501; 23.502; 23.503; 23.304; 23.316 | Gan, Judy, Ericsson | Judy.Gan.Juying@ericsson.com | Rel-18 | 97 |
| 707 | 359.1 | Stage 2 of TEI18_IPv6PD | 127d | 2022-09-08 A | 2023-03-03 A | 100% |  |  | finish no earlier than 2023-03-03 | S2 | 1016h | 1016h | TEI18_IPv6PD | 49 | 23.501; 23.502; 23.503; 23.304; 23.316 | Gan, Judy, Ericsson | Judy.Gan.Juying@ericsson.com | Rel-18 | 97 |
| 708 | 359.2 | CT1 aspects of TEI18_IPv6PD | 259d | 2022-12-16 A | 2023-12-12 A | 100% |  |  | finish no earlier than 2023-12-12 | C1 | 2072h | 2072h | TEI18_IPv6PD | 49 | 24.501; 29.561; 29.512; 29.521; 29.244; 29.513 | Maria Tianmei, Liang, Ericsson | Maria.liang@ericsson.com | Rel-18 | 97 |
| 709 | 359.3 | CT3 aspects of TEI18_IPv6PD | 259d | 2022-12-16 A | 2023-12-12 A | 100% |  |  | finish no earlier than 2023-12-12 | C3 | 2072h | 2072h | TEI18_IPv6PD | 49 | 24.501; 29.561; 29.512; 29.521; 29.244; 29.513 | Maria Tianmei, Liang, Ericsson | Maria.liang@ericsson.com | Rel-18 | 97 |
| 710 | 359.4 | CT4 aspects of TEI18_IPv6PD | 259d | 2022-12-16 A | 2023-12-12 A | 100% |  |  | finish no earlier than 2023-12-12 | C4 | 2072h | 2072h | TEI18_IPv6PD | 49 | 24.501; 29.561; 29.512; 29.521; 29.244; 29.513 | Maria Tianmei, Liang, Ericsson | Maria.liang@ericsson.com | Rel-18 | 97 |
| 711 | 360 | **Secondary DN Authentication and authorization in EPC IWK cases** | 389d | 2022-09-08 A | 2024-03-03 A | 100% |  |  |  |  | 8176h | 8176h | TEI18_SDNAEPC | 49 | 23.501; 23.502 | Laurent Thiebaut, Nokia | Laurent.thiebaut@nokia.com | Rel-18 | 97 |
| 712 | 360.1 | Stage 2 of Secondary DN Authentication and authorization in EPC IWK cases | 68d | 2022-09-08 A | 2022-12-12 A | 100% |  |  | finish no earlier than 2022-12-12 | S2 | 544h | 544h | TEI18_SDNAEPC | 49 | 23.501; 23.502 | Laurent Thiebaut, Nokia | Laurent.thiebaut@nokia.com | Rel-18 | 97 |
| 713 | 360.2 | CT1 aspects of TEI18_SDNAEPC | 318d | 2022-12-16 A | 2024-03-03 A | 100% |  |  | finish no earlier than 2024-03-03 | C1 | 2544h | 2544h | TEI18_SDNAEPC | 49 | 24.501; 24.301; 24.008; 29.561; 29.274 | Nassar, Mohamed A.(Nokia) | mohamed.a.nassar@nokia.com | Rel-18 | 97 |
| 714 | 360.3 | CT3 aspects of TEI18_SDNAEPC | 318d | 2022-12-16 A | 2024-03-03 A | 100% |  |  | finish no earlier than 2024-03-03 | C3 | 2544h | 2544h | TEI18_SDNAEPC | 49 | 24.501; 24.301; 24.008; 29.561; 29.274 | Nassar, Mohamed A.(Nokia) | mohamed.a.nassar@nokia.com | Rel-18 | 97 |
| 715 | 360.4 | CT4 aspects of TEI18_SDNAEPC | 318d | 2022-12-16 A | 2024-03-03 A | 100% |  |  | finish no earlier than 2024-03-03 | C4 | 2544h | 2544h | TEI18_SDNAEPC | 49 | 24.501; 24.301; 24.008; 29.561; 29.274 | Nassar, Mohamed A.(Nokia) | mohamed.a.nassar@nokia.com | Rel-18 | 97 |

Notes:
- 689: ; 9/1/23: WID:SP-220802->SP-221336; 15/3/23: 0%->60; 15/3/23: WID:SP-221336->SP-230120; 15/3/23: FCD:03/03/2023->/23; 8/6/23: 60%->100
- 690: ; 6/6/23: Compl:10%->90%; 6/6/23: CD:12/12/2023->03/03/2024; 6/6/23: WID: CP-223210->CP-231193. 2/4/23: rapporteur: Thomas Luetzenkirchen, Intel-> Yue Sun, China Telecom
- 691: ; 6/6/23: Compl:100%->80%; 6/6/23: CD:12/12/2022->12/12/2023; 6/6/23: WID: CP-223210->CP-231193. 2/4/23: rapporteur: Thomas Luetzenkirchen, Intel-> Yue Sun, China Telecom
- 692: 21/1/22: 23.700-18 added;; 12/3/22: 0%->25; 4/6/22: 25%->60; 21/6/22: WID:SP-211594->SP-220415: rap change; 12/9/22: 60%->80; 12/9/22: FCD:12/09/2022->12/22; 10/12/22: 80%->100
- 693: 21/1/22: 23.700-46 added;; 12/3/22: 0%->10; 4/6/22: 10%->70; 12/9/22: 70%->90; 12/9/22: FCD:12/09/2022->12/22; 15/3/23: 90%->100
- 695: ; 15/3/23: WID:SP-220801->SP-230172; 15/3/23: FCD:03/03/2023->/23; 8/6/23: 95%->100
- 696: ; 6/6/23: Compl:90%->100%; 6/6/23: WID: CP-223206->CP-231195
- 697: ; 6/6/23: Compl:50%->80%; 6/6/23: CD:12/12/2023->03/03/2024; 6/6/23: WID: CP-223206->CP-231195
- 698: 2/4/24: 100%->25
- 699: ; 6/6/23: Compl:10%->80%; 6/6/23: WID: CP-223206->CP-231195
- 701: ; 10/12/22: 0%->100
- 702: ; 6/6/23: Compl:80%->100%; 6/6/23: CD:12/12/2023->06/06/2023
- 704: ; 22/3/23: 0%->100
- 705: ; 6/6/23: Compl:0%->100%
- 707: ; 22/3/23: 0%->100
- 708: ; 6/6/23: Compl:95%->100%; 6/6/23: WID: CP-223203->CP-230121
- 712: ; 10/12/22: 0%->100
- 713: ; 6/6/23: Compl:80%->90%
- 714: ; 9/6/23: 96%->

| ID | WBS | Task | Duration | Start | Finish | Complete | Remaining | Total slack | Constraint | Resources | Work | Actual work | Acronym | PCG approved | WI rapporteur name | WI rapporteur e-mail | Release | TSG approved | Status Report |
| --- | --- | --- | --- | --- | --- | --- | --- | --- | --- | --- | --- | --- | --- | --- | --- | --- | --- | --- | --- |
| 716 | 361 | **Message Service within the 5G system (MSGin5G) Phase 2** | 463d | 2022-03-10 A | 2023-12-15 | 99% | 6.83d | 579d |  |  | 5448h | 3840h | 5GMARCH_Ph2 | 48 | Liu, Yue, China Mobile | liuyueyjy@chinamobile.com | Rel-18 | 95 |  |
| 717 | 361.1 | Stage 2 of 5GMARCH_Ph2 | 257d | 2022-03-10 A | 2023-03-03 A | 100% |  |  | finish no earlier than 2023-03-03 | S6 | 2056h | 2056h | 5GMARCH_Ph2 | 48 | Liu, Yue, China Mobile | liuyueyjy@chinamobile.com | Rel-18 | 95 |  |
| 718 | 361.2 | CT1 aspects of 5GMARCH_Ph2 | 201d | 2023-03-13 A | 2023-12-15 | 95% | 10.05d | 579d | finish no earlier than 2023-12-15 | C1 | 1608h |  | 5GMARCH_Ph2 | 48 | Liu, Yue, China Mobile | liuyueyjy@chinamobile.com | Rel-18 | 95 |  |
| 719 | 361.3 | CT3 aspects of 5GMARCH_Ph2 | 201d | 2023-03-13 A | 2023-12-15 A | 100% |  |  | finish no earlier than 2023-12-15 | C3 | 1608h | 1608h | 5GMARCH_Ph2 | 48 | Liu, Yue, China Mobile | liuyueyjy@chinamobile.com | Rel-18 | 95 |  |
| 720 | 361.4 | Security aspects of MSGin5G Ph2 | 22d | 2023-02-02 A | 2023-03-03 A | 100% |  |  | finish no earlier than 2023-03-03 | S3 | 176h | 176h | 5GMARCH_Ph2_SEC | 50 | Huang Xiaoting, China Mobile | huangxiaoting@chinamobile.com | Rel-18 | 99 |  |
| 721 | 362 | **5G Timing Resiliency System** | 965d | 2020-06-25 A | 2024-03-03 | 99% | 5.06d | 523d |  |  | 12720h | 8104h | 5TRS | 46 | Betsy Covell, Nokia | betsy.covell@nokia.com | Rel-18 | 91 |  |
| 722 | 362.1 | Study on 5TRS | 187d | 2020-06-25 A | 2021-03-12 A | 100% |  |  | finish no earlier than 2021-03-12 | S1 | 1496h | 1496h | FS_5TRS | 45 | Betsy Covell, Nokia | betsy.covell@nokia.com | Rel-18 | 88 |  |
| 723 | 362.2 | Study on 5G Timing Resiliency and TSC&URLLC enhancements | 256d | 2021-12-20 A | 2022-12-12 A | 100% |  |  | finish no earlier than 2022-12-12 | S2 | 2048h | 2048h | FS_5TRS_URLLC | 48 | Devaki Chandramouli | Devaki.chandramouli@nokia.com | Rel-18 | 94 |  |
| 724 | 362.3 | Stage 1 for 5TRS | 127d | 2021-03-18 A | 2021-09-10 A | 100% |  |  | finish no earlier than 2021-09-12 | S1 | 1016h | 1016h | 5TRS | 46 | Betsy Covell, Nokia | betsy.covell@nokia.com | Rel-18 | 91 |  |
| 725 | 362.4 | Stage 2 of Timing Resiliency and URLLC enhancements | 125d | 2022-09-12 A | 2023-03-03 A | 100% |  |  | finish no earlier than 2023-03-03 | S2 | 1000h | 1000h | TRS_URLLC | 49 | Devaki Chandramouli | Devaki.chandramouli@nokia.com | Rel-18 | 97 |  |
| 726 | 362.5 | CT1 aspects of TRS_URLLC | 318d | 2022-12-16 A | 2024-03-03 A | 100% |  |  | finish no earlier than 2024-03-03 | C1 | 2544h | 2544h | TRS_URLLC | 49 | Apostolos Papageorgiou (Nokia) | apostolos.papageorgiou@nokia.com | Rel-18 | 97 |  |
| 727 | 362.6 | CT3 aspects of TRS_URLLC | 318d | 2022-12-16 A | 2024-03-03 | 99% | 3.18d | 523d | finish no earlier than 2024-03-03 | C3 | 2544h |  | TRS_URLLC | 49 | Apostolos Papageorgiou (Nokia) | apostolos.papageorgiou@nokia.com | Rel-18 | 97 |  |
| 728 | 362.7 | CT4 aspects of TRS_URLLC | 259d | 2022-12-16 A | 2023-12-12 | 98% | 5.18d | 582d | finish no earlier than 2023-12-12 | C4 | 2072h |  | TRS_URLLC | 49 | Apostolos Papageorgiou (Nokia) | apostolos.papageorgiou@nokia.com | Rel-18 | 97 |  |
| 729 | 363 | Study on Management Aspects of URLLC | 324d | 2022-03-10 A | 2023-06-06 A | 100% |  |  | finish no earlier than 2023-06-06 | S5 | 2592h | 2592h | FS_URLLC_Mgt | 48 | Wang,Zhaoning,China Unicom | wangzn18@chinaunicom.cn | Rel-18 | 95 |  |
| 730 | 364 | Study on enhancement for resiliency of gNB-CU (Central Unit)-CP (Control Plane) | 204d | 2021-12-13 A | 2022-09-22 A | 100% |  |  | finish no earlier than 2022-09-22 | R3 | 1632h | 1632h | FS_gNB_CU_CP_resiliency | 48 | Masato Taniguchi, NTT DOCOMO, INC. | masato.taniguchi.mf@nttdocomo.com | Rel-18 | 94 | RP-221439 |
| 731 | 365 | **NR Timing Resiliency and URLLC enhancements** | 204d | 2023-03-03 A | 2023-12-12 A | 100% |  |  |  | R3 | 3264h | 3264h | TRS_URLLC-NR | 50 | Nokia |  | Rel-18 | 99 |  |
| 732 | 365.1 | Core part: NR Timing Resiliency and URLLC enhancements | 204d | 2023-03-03 A | 2023-12-12 A | 100% |  |  | finish no earlier than 2023-12-12 | R3 | 1632h | 1632h | TRS_URLLC-NR-Core | 50 | Sean Kelley, Nokia | sean.kelley@nokia.com | Rel-18 | 99 | RP-232864 |
| 733 | 366 | **Vehicle-Mounted Relays** | 906d | 2020-09-16 A | 2024-03-03 A | 100% |  |  |  |  | 9760h | 9760h | VMR | 47 | Francesco Pica, Qualcomm | fpica@qti.qualcomm.com | Rel-18 | 93 |  |
| 734 | 366.1 | Study on VMR | 256d | 2020-09-16 A | 2021-09-08 A | 100% |  |  | finish no earlier than 2021-09-08 | S1 | 2048h | 2048h | FS_VMR | 45 | Francesco Pica | fpica@qti.qualcomm.com | Rel-18 | 89 |  |
| 735 | 366.2 | Stage 1 of VMR | 66d | 2021-09-10 A | 2021-12-10 A | 100% |  |  | finish no earlier than 2021-12-12 | S1 | 528h | 528h | VMR | 47 | Francesco Pica, Qualcomm | fpica@qti.qualcomm.com | Rel-18 | 93 |  |
| 736 | 366.3 | (Stage 2 for VMR) Architecture Enhancements for Vehicle Mounted Relays | 128d | 2022-12-09 A | 2023-06-06 A | 100% |  |  | finish no earlier than 2023-06-06 | S2 | 1024h | 1024h | VMR | 50 | Cheng, Hong, Qualcomm Incorporated, | hongc@qti.qualcomm.com | Rel-18 | 98 |  |
| 737 | 366.4 | CT1 aspects of VMR | 257d | 2023-03-13 A | 2024-03-03 A | 100% |  |  | finish no earlier than 2024-03-03 | C1 | 2056h | 2056h | VMR | 50 | Kim, Sunghoon, Qualcomm Incorporated | sunghoon@qti.qualcomm.com | Rel-18 | 99 |  |
| 738 | 366.5 | CT4 aspects of VMR | 257d | 2023-03-13 A | 2024-03-03 A | 100% |  |  | finish no earlier than 2024-03-03 | C4 | 2056h | 2056h | VMR | 50 | Kim, Sunghoon, Qualcomm Incorporated | sunghoon@qti.qualcomm.com | Rel-18 | 99 |  |
| 739 | 366.6 | Study on Architecture Enhancements for Vehicle Mounted Relays | 256d | 2021-12-20 A | 2022-12-12 A | 100% |  |  | finish no earlier than 2022-12-12 | S2 | 2048h | 2048h | FS_VMR | 48 | Cheng, Hong, Qualcomm Incorporated, | hongc@qti.qualcomm.com | Rel-18 | 94 |  |

Notes:
- 716: ; 4/6/22: 0%->30; 12/9/22: 30%->55; 11/12/22: 55%->70 / Impacted TSs and TRs: 23.554
- 717: ; 4/6/22: 0%->30; 12/9/22: 30%->55; 11/12/22: 55%->70; 17/3/23: 70%->80; 8/6/23: 80%->100 / Impacted TSs and TRs: 23.554
- 718: ; 6/6/23: Compl:0%->15% / Impacted TSs and TRs: 24.538; 24.544; 24.546; 29.538; 29.222
- 719: 9/6/23: 0%->80 / Impacted TSs and TRs: 24.538; 24.544; 24.546; 29.538; 29.222
- 720: ; 8/6/23: 0%->100 / Impacted TSs and TRs: 33.501
- 721: Impacted TSs and TRs: 22.261; 22.104
- 722: 28/7/20: 22.878 added;; 12/9/20: 0%->10; 5/12/20: 10%->75; 19/3/21: FCD:16/12/2020->03/21; 19/3/21: 75%->97; 11/6/21: 97%->100 / Impacted TSs and TRs: 22.878
- 723: 21/1/22: 23.700-25 added;; 12/3/22: 0%->25; 4/6/22: 25%->65; 12/9/22: 65%->83; 12/9/22: FCD:12/09/2022->12/22; 10/12/22: 83%->98; 15/3/23: 98%->100 / Impacted TSs and TRs: 23.700-25
- 724: ; 11/6/21: 0%->100 / Impacted TSs and TRs: 22.261; 22.104
- 725: ; 10/12/22: 0%->50; 9/1/23: WID:SP-220814->SP-221341; 15/3/23: 50%->80; 15/3/23: WID:SP-221341->SP-230107; 8/6/23: 80%->100 / Impacted TSs and TRs: 23.501; 23.502; 23.503
- 726: ; 6/6/23: Compl:70%->95%; 6/6/23: WID: CP-223205->CP-231198; 30/6/23: WID:CP-231198->CP-231360 / Impacted TSs and TRs: 24.501; 29.122; 29.507; 29.512; 29.513; 29.514; 29.522; 29.534; 29.565; 29.503; 29.504; 29.505; 29.518; 29.571; 29.244.24.539
- 727: ; 6/6/23: Compl:25%->75%; 6/6/23: WID: CP-223205->CP-231198 / Impacted TSs and TRs: 24.501; 29.122; 29.507; 29.512; 29.513; 29.514; 29.522; 29.534; 29.565; 29.503; 29.504; 29.505; 29.518; 29.571; 29.244.24.539
- 728: ; 6/6/23: Compl:40%->55%; 6/6/23: WID: CP-223205->CP-231198; 30/6/23: 29.585 added; / Impacted TSs and TRs: 24.501; 29.122; 29.507; 29.512; 29.513; 29.514; 29.522; 29.534; 29.565; 29.503; 29.504; 29.505; 29.518; 29.571; 29.244; 29.585
- 729: 5/4/22: 28.832 added;; 4/6/22: 0%->15; 12/9/22: 15%->40; 12/9/22: FCD:12/09/2022->03/23; 11/12/22: 40%->60; 17/3/23: 60%->62; 17/3/23: FCD:03/03/2023->/23; 8/6/23: 62%->100; 30/6/23: WID:SP-220146->SP-230772 / Impacted TSs and TRs: 28.832
- 730: ; 22/3/22: CD:12/09/2022->12/09/2023; 22/3/22: Stat Rep: ->RP-2205556/6/22: CD:12/09/2023->22/09/20226/6/22: Stat Rep: RP-220555->RP-221439; 20/6/22: Rapporteur: NTT DOCOMO->Masato Taniguchi, NTT DOCOMO, INC.; Rap eMail: ->masato.taniguchi.mf@nttdocomo...; 23/9/22: 38.879 added; / Impacted TSs and TRs: 38.879
- 731: 2/1/24: WID:RP-230754->RP-232863
- 732: ; ...; 6/9/23: Compl:25%->60%; WID: RP-230754->RP-231106; Stat Rep: ->RP-231581; Rapporteur: Nokia->Sean Kelley, Nokia; Rap eMail: ->sean.kelley@nokia.com; ; 8/12/23: Compl:60%->100%; Stat Rep: RP-231581->RP-232864;
- 733: Impacted TSs and TRs: 22.261
- 734: 5/12/20: 0%->35; 19/3/21: FCD:11/06/2021->09/21; 19/3/21: 35%->60; 11/6/21: 60%->85; 13/9/21: 85%->100 / Impacted TSs and TRs: 22.839
- 735: ; 13/9/21: 0%->95; 14/12/21: 95%->100 / Impacted TSs and TRs: 22.261
- 736: ; 10/12/22: 0%->20; 15/3/23: WID:SP-221328->SP-230105; 15/3/23: 20%->40; 8/6/23: 40%->100; 4/1/24: 28.875 added; / Impacted TSs and TRs: 23.501; 23.502; 23.503; 23.273 ; 28.875
- 737: ; 6/6/23: Compl:0%->20% / Impacted TSs and TRs: 23.122.23.041.24.501.24.526.27.007.29.513.29.519.29.522.29.525.23.008.29.503.29.505.29.510.29.515.29.518.29.571.29.572
- 738: ; 6/6/23: Compl:0%->25% / Impacted TSs and TRs: 23.122.23.041.24.501.24.526.27.007.29.513.29.519.29.522.29.525.23.008.29.503.29.505.29.510.29.515.29.518.29.571.29.572
- 739: 21/1/22: 23.700-05 added;; 12/3/22: 0%->20; 4/6/22: 20%->55; 12/9/22: 55%->80; 12/9/22: FCD:12/09/2022->12/22; 10/12/22: 80%->100 / Impacted TSs and TRs: 23.700-05

| ID | WBS | Task | Duration | Start | Finish | Complete | Remaining | Total slack | Constraint | Resources | Work | Actual work | Acronym | PCG approved | WI rapporteur name | Release | TSG approved | WI rapporteur e-mail | Status Report |
| --- | --- | --- | --- | --- | --- | --- | --- | --- | --- | --- | --- | --- | --- | --- | --- | --- | --- | --- | --- |
| 740 | 367 | **Mobile IAB (Integrated Access and Backhaul) for NR** | 652d | 2021-12-13 A | 2024-06-06 | 78% | 144.52d | 453d |  |  | 9384h | 4184h | NR_mobile_IAB | 48 | Qualcomm | Rel-18 | 94 |  |  |
| 741 | 367.1 | Core part: Mobile IAB (Integrated Access and Backhaul) for NR | 523d | 2021-12-13 A | 2023-12-12 A | 100% |  |  | finish no earlier than 2023-12-12 | R3 | 4184h | 4184h | NR_mobile_IAB-Core | 48 | Georg Hampel, Qualcomm Incorporated | Rel-18 | 94 | ghampel@qti.qualcomm.com | RP-240103 |
| 742 | 367.2 | Perf. part: Mobile IAB (Integrated Access and Backhaul) for NR | 650d | 2021-12-15 A | 2024-06-06 | 60% | 260d | 453d | finish no earlier than 2024-06-06 | R3 | 5200h |  | NR_mobile_IAB-Perf | 48 | Georg Hampel, Qualcomm Incorporated | Rel-18 | 94 | ghampel@qti.qualcomm.com | RP-240103 |
| 743 | 368 | **Enhancement on NR QoE management and optimizations for diverse services** | 523d | 2021-12-13 A | 2023-12-12 A | 100% |  |  |  |  | 4184h | 4184h | NR_QoE_enh | 48 | China Unicom | Rel-18 | 94 |  |  |
| 744 | 368.1 | Core part: Enhancement on NR QoE management and optimizations for diverse services | 523d | 2021-12-13 A | 2023-12-12 A | 100% |  |  | finish no earlier than 2023-12-12 | R3 | 4184h | 4184h | NR_QoE_enh-Core | 48 | Pei Li, China Unicom | Rel-18 | 94 | lip104@chinaunicom.cn | RP-233603 |
| 745 | 369 | Study on Key Quality Indicators (KQIs) for 5G service experience | 582d | 2021-12-13 A | 2024-03-03 A | 100% |  |  | finish no earlier than 2024-03-03 | S5 | 4656h | 4656h | FS_KQI_5G | 48 | Man WANG, Huawei | Rel-18 | 94 | wangman1@huawei.com |  |
| 746 | 370 | Additional NRM features phase 2 | 519d | 2022-03-10 A | 2024-03-03 A | 100% |  |  | finish no earlier than 2024-03-03 | S5 | 4152h | 4152h | AdNRM_ph2 | 48 | Sean Sun, Nokia | Rel-18 | 95 | sean.sun@nokia-sbell.com |  |
| 747 | 371 | **MPS when access to EPC/5GC is WLAN** | 649d | 2021-09-10 A | 2024-03-03 | 80% | 128.64d | 523d |  |  | 8264h | 5144h | MPS_WLAN | 48 | Singh, Ray; Peraton Labs | Rel-18 | 94 | rsingh@peratonlabs.com |  |
| 748 | 371.1 | Stage 1 of MPS_WLAN | 66d | 2021-09-10 A | 2021-12-10 A | 100% |  |  | finish no earlier than 2021-12-12 | S1 | 528h | 528h | MPS_WLAN | 47 | Singh, Ray; Peraton Labs | Rel-18 | 93 | rsingh@peratonlabs.com |  |
| 749 | 371.2 | Stage 2 of MPS_WLAN | 382d | 2021-12-20 A | 2023-06-06 A | 100% |  |  | finish no earlier than 2023-06-06 | S2 | 3056h | 3056h | MPS_WLAN | 48 | Robert C Streijl; Peraton Labs | Rel-18 | 94 | rstreijl@peratonlabs.com |  |
| 750 | 371.3 | CT1 aspects of MPS_WLAN | 195d | 2023-06-07 A | 2024-03-03 | 95% | 9.75d | 523d | finish no earlier than 2024-03-03 | C1 | 1560h |  | MPS_WLAN | 51 | Monnes, Peter, Peraton Labs | Rel-18 | 100 | pmonnes@peratonlabs.com |  |
| 751 | 371.4 | CT4 aspects of MPS_WLAN | 195d | 2023-06-07 A | 2024-03-03 A | 100% |  |  | finish no earlier than 2024-03-03 | C4 | 1560h | 1560h | MPS_WLAN | 51 | Monnes, Peter, Peraton Labs | Rel-18 | 100 | pmonnes@peratonlabs.com |  |
| 752 | 371.5 | CT6 aspects of MPS_WLAN | 195d | 2023-06-07 | 2024-03-03 |  |  | 523d | finish no earlier than 2024-03-03 | C6 | 1560h |  | MPS_WLAN | 51 | Monnes, Peter, Peraton Labs | Rel-18 | 100 | pmonnes@peratonlabs.com |  |
| 753 | 372 | **Further enhancement of data collection for SON (Self-Organising Networks)/MDT (Minimization of Drive Tests) in NR and EN-DC** | 770d | 2021-01-01 A | 2023-12-12 A | 100% |  |  |  |  | 9360h | 9360h | NR_ENDC_SON_MDT_enh2 | 48 | CMCC | Rel-18 | 94 |  |  |
| 754 | 372.1 | Core part: Further enhancement of data collection for SON (Self-Organising Networks)/MDT (Minimization of Drive Tests) in NR and EN-DC | 770d | 2021-01-01 A | 2023-12-12 A | 100% |  |  | finish no earlier than 2023-12-12 | R3 | 6160h | 6160h | NR_ENDC_SON_MDT_enh2-Core | 48 | Liang LIU, CMCC | Rel-18 | 94 | liuliang@chinamobile.com | RP-233437 |
| 755 | 372.2 | UE Conformance - Enhancement of data collection for SON (Self-Organising Networks)/MDT (Minimization of Drive Tests) in NR standalone and MR-DC (Multi-Radio Dual Connectivity) | 400d | 2022-03-15 A | 2023-09-22 A | 100% |  |  | finish no earlier than 2023-09-22 | R5 | 3200h | 3200h | NR_ENDC_SON_MDT_enh-UEConTest | 48 | Danni Song, CMCC | Rel-17 | 95 | songdan@chinamobile.com | RP-232241 |
| 756 | 373 | Self-Configuration of RAN Network Entities | 584d | 2021-12-10 A | 2024-03-03 A | 100% |  |  | finish no earlier than 2024-03-03 | S5 | 4672h | 4672h | RANSC | 48 | Hu, Yaxi, China Mobile | Rel-18 | 94 | huyaxi@cmdi.chinamobile.com |  |
| 757 | 374 | Support for Service Function Chaining | 71d | 2020-12-04 A | 2021-03-12 A | 100% |  |  | finish no earlier than 2021-03-12 | S1 | 568h | 568h | SFChain | 46 | Ellen Liao; Intel | Rel-18 | 90 | ellen.c.liao at intel.com |  |
| 758 | 375 | Data Integrity in 5GS | 6d | 2021-03-18 A | 2021-03-25 A | 100% |  |  | finish no earlier than 2021-03-25 | S1 | 48h | 48h | DI_5G | 46 | Qun wei, China Unicom | Rel-18 | 91 | Weiqun5 <at> chinaunicom.cn |  |
| 759 | 376 | **Signal level Enhanced Network Selection** | 382d | 2022-09-16 A | 2024-03-01 | 99% | 0d | 0d |  | S1 | 5056h | 2512h | SENSE | 47 | Bischinger, Kurt; Deutsche Telekom | Rel-18 | 92 | kurt.bischinger@magenta.at |  |
| 760 | 376.1 | CT1 aspects of SENSE | 123d | 2022-12-16 A | 2023-06-06 A | 100% |  |  | finish no earlier than 2023-06-06 | C1 | 984h | 984h | SENSE | 49 | Reinhard Lauster, Deutsche Telekom | Rel-18 | 97 | reinhard.lauster@magenta.at |  |
| 761 | 376.2 | CT6 aspects of SENSE | 1d | 2022-09-16 A | 2022-09-16 A | 100% |  |  | finish no earlier than 2022-09-16 | C6 | 8h | 8h | SENSE | 49 | Reinhard Lauster, Deutsche Telekom | Rel-18 | 97 | reinhard.lauster@magenta.at |  |
| 762 | 376.3 | UE Conformance - Signal level Enhanced Network Selection | 126d | 2023-09-09 A | 2024-03-01 A | 100% |  |  | finish no earlier than 2024-03-01 | R5 | 1008h | 1008h | SENSE-UEContest | 51 | Ya Zhao, Huawei Technologies. Co., Ltd | Rel-18 | 101 | zhaoya@hisilicon.com | RP-240288 |
| 763 | 377 | SECAM and SCAS for 3GPP virtualized network products | 322d | 2021-12-10 A | 2023-03-03 A | 100% |  |  | finish no earlier than 2023-03-03 | S3 | 2576h | 2576h | VNP_SECAM_SCAS | 48 | Qi Minpeng, China Mobile | Rel-18 | 94 | qiminpeng@chinamobile.com |  |
| 764 | 378 | Security Assurance Specification (SCAS) for 5G Rel-17 Features | 198d | 2022-03-10 A | 2022-12-12 A | 100% |  |  | finish no earlier than 2022-12-12 | S3 | 1584h | 1584h | SCAS_5G_Ph2 | 48 | Rong Wu, Huawei Technologies Co., Ltd. | Rel-18 | 95 | Raina.wu@huawei.com |  |
| 765 | 379 | Study on URSP rules to securely identify applications | 197d | 2022-06-02 A | 2023-03-03 A | 100% |  |  | finish no earlier than 2023-03-03 | S3 | 1576h | 1576h | FS_USIA | 49 | Andreas Kunz, Lenovo | Rel-18 | 96 | akunz@lenovo.com |  |
| 766 | 380 | Study on 5G security enhancement against false base stations | 1113d? | 2018-09-06 A | 2022-12-09 A | 100% |  |  | finish no earlier than 2022-12-12 | S3 | 8904h | 8904h | FS_5GFBS | 41 | Ivy Guo, Apple | Rel-18 | 81 | ivy_guo@apple.com |  |
| 767 | 381 | Security Enhancement on RRCResumeRequest Message Protection | 138d | 2022-06-02 A | 2022-12-12 A | 100% |  |  | finish no earlier than 2022-12-12 | S3 | 1104h | 1104h | SERP | 49 | Ivy Guo, Apple | Rel-18 | 96 | <ivy_guo@apple.com> |  |

Notes:
- 740: compare REL-16 WI NR_IAB and REL-17 WI NR_IAB_enh; no Perf. part; 5/4/22: WID:RP-213601->RP-220843; 12/7/22: WID:RP-220843->RP-221815; 23/9/22: WID:RP-221815->RP-222671; 6/10/23: WID:RP-222671->RP-232643; 2/1/24: WID:RP-232643->RP-233320; 2/4/24: WID:RP-233320->RP-240104
- 741: compare REL-16 WI NR_IAB and REL-17 WI NR_IAB_enh;; 22/3/22: Stat Rep: ->RP-220430 6/6/22: CD:12/12/2023->23/12/2022 6/6/22: Stat Rep: RP- ; 20/6/22: Rapporteur: Qualcomm->Georg Hampel, Qualcomm Incorporated; Rap eMail: ->ghampel@qti.qualcomm.com13...;...; 14/3/24: Stat Rep: RP-233319->RP-240103;
- 742: ; 22/3/22: CD:24/06/2024->12/06/2024; 22/3/22: Stat Rep: ->RP-220430 ; 6/6/22: CD:12/06/2024->24/06/2022 ; 6/6/22: Stat Rep: RP-220430->RP ; 20/6/22: WG: R4->R3; Rapporteur: Qualcomm->Georg Hampel, Qualcomm Incorporated; Rap eMail: ->ghampel@qti.qualco...; 14/3/24: FCD:05/06/2024->06/06/2024; Compl:20%->60%; Stat Rep: RP-233319->RP-240103;
- 743: compare REL-17 WI NR_QoE-Core; QoE = Quality of Experience; no Perf. part; 12/7/22: WID:RP-213594->RP-221803; 9/1/23: WID:RP-221803->RP-223488
- 744: compare REL-17 WI NR_QoE-Core; QoE = Quality of Experience; no Perf. part; 20/6/22: FCD:12/12/2023->23/12/2022; Stat Rep: ->RP-221244; Rapporteur: China Unicom->Pei Li, China Unicom; Rap eMail: ->lip104@chinaunicom.cn13/7/22: FCD:23/12/2022->12/20;...;...; 8/12/23: Compl:70%->100%; Stat Rep: RP-232394->RP-233603;
- 745: 7/1/22: 28.863 added;; 4/6/22: 0%->10; 12/9/22: 10%->20; 11/12/22: FCD:12/12/2022->/23; 17/3/23: 20%->35; 17/3/23: FCD:03/03/2023->/23; 8/6/23: 35%->; 8/6/23: FCD:06/06/2023->/24; 7/9/23: 35%->65; 8/12/23: 65%->100; 3/1/24: WID:SP-211433->SP-231432 / Impacted TSs and TRs: 28.863
- 746: 4/6/22: 0%->7; 12/9/22: 7%->30; 12/9/22: FCD:11/03/2022->03/23; 11/12/22: 30%->55; 17/3/23: 55%->65; 8/6/23: 65%->80; 8/6/23: FCD:03/03/2023->/24; 8/6/23: 80%->; 7/9/23: 80%->88; 8/12/23: 88%->99; 3/1/24: WID:SP-220351->SP-231440; 14/3/24: 99%->100
- 748: 10/12/21: 0%->100 / Impacted TSs and TRs: 22.153
- 749: ; 10/12/22: 0%->0; 10/12/22: FCD:12/09/2022->03/23; 15/3/23: 0%->50; 15/3/23: WID:SP-211595->SP-230108; 15/3/23: FCD:03/03/2023->/23; 8/6/23: 50%->100 / Impacted TSs and TRs: 23.401; 23.402; 23.501; 23.502
- 750: Impacted TSs and TRs: 23.003; 24.302; 24.502; 29.273
- 751: Impacted TSs and TRs: 23.003; 24.302; 24.502; 29.273
- 752: Impacted TSs and TRs: 23.003; 24.302; 24.502; 29.273
- 753: compare REL-16 WI NR_SON_MDT-Core and REL-17 WI NR_ENDC_SON_MDT_enh-Core; no Perf. part; 5/4/22: WID:RP-213553->RP-221000; 12/7/22: WID:RP-221000->RP-221825; 2/1/24: WID:RP-221825->RP-233438
- 754: compare REL-16 WI NR_SON_MDT-Core and REL-17 WI NR_ENDC_SON_MDT_enh-Core; no Perf. part; 20/6/22: FCD:31/12/2021->23/12/2022; Stat Rep: ->RP-221372; Rapporteur: CMCC->Liang LIU, CMCC; Rap eMail: ->liuliang@chinamobile.com13/7/22: FCD:23/12/2022->12...;...; 8/12/23: Compl:80%->100%; Stat Rep: RP-232234->RP-233437;
- 755: tested: REL-17 WI NR_ENDC_SON_MDT_enh 6/6/22: Compl:0%->5% 6/6/22: CD:15/06/2 ; 20/6/22: Rapporteur: CMCC->Luting Kong, CMCC; Rap eMail: ->kongluting@chinamobile.com12/7/22: WID:RP-220620->RP-221365 ...; 9/12/22: FCD:23/06/2023->01/06/2023; Compl:7%-...; 6/10/23: WID:RP-223069->RP-232426
- 756: ; 7/1/22: 28.317 added;; 4/6/22: 0%->5; 11/12/22: 5%->45; 17/3/23: 45%->50; 17/3/23: FCD:06/06/2023->12/23; 8/6/23: 50%->55; 8/6/23: 55%->55; 7/9/23: 55%->65; 8/12/23: 65%->90; 8/12/23: FCD:12/12/2023->/2024; 14/3/24: 90%->100 / Impacted TSs and TRs: 28.313; ; 28.317
- 757: 22.261; 22.101; 22.115 ; 5/12/20: 0%->100
- 758: ; 19/3/21: 0%->100 / Impacted TSs and TRs: 22.261
- 759: ; 11/6/21: 0%->40; 10/12/21: 40%->100 / Impacted TSs and TRs: 22.011
- 760: ; 6/6/23: Compl:65%->95%; 6/6/23: CD:16/12/2022->06/06/2023 / Impacted TSs and TRs: 23.122; 24.501; 27.007
- 761: Impacted TSs and TRs: 31.102
- 762: 8/12/23: Compl:0%->5%; Stat Rep: ->RP-233769; Rapporteur: Huawei->Ya Zhao, Huawei Technologies. Co., Ltd; Rap eMail: ->zhaoya@hisilicon.com; ; 2/1/24: WID:RP-232362->RP-233770; 14/3/24: FCD:05/06/2024->01/03/2024; Compl:5%->100%; Stat Rep: RP-233769->RP-240288;
- 763: 7/1/22: 33.527 added;; 12/9/22: 0%->40; 11/12/22: 40%->65; 17/3/23: 65%->75; 15/3/24: 75%->100 / Impacted TSs and TRs: 33.527; 33.927; 33.936
- 764: ; 4/6/22: 0%->10; 17/3/23: 10%->30; 15/3/24: 30%->100 / Impacted TSs and TRs: 33.926; 33.117; 33.511; 33.512; 33.513; 33.514; 33.515; 33.516; 33.517; 33.518; 33.519; 33.520; 33.521; 33.522; 33.326
- 765: 13/7/22: 33.892 added;; 12/9/22: 0%->30; 11/12/22: 30%->50; 17/3/23: 50%->80; 7/9/23: 80%->100 / Impacted TSs and TRs: 33.892
- 766: 7/12/18: 0%->10¦20/3/19: FCD:019->09/19¦20/3/19: 10%->50; 31/5/19: 50%->65; 13/9/19: 65%->66; 13/9/19: FCD:12/09/2019->12/20; 6/12/19: 66%->75; 6/12/19: FCD:12/12/2019->03/20; 25/03/20: Rel-16->Rel-17; 26/6/20: 75%->80; 26/6/20: FCD:12/03/2020->12/20; ; 8/6/23: 90%->100 / Impacted TSs and TRs: New
- 767: 7/9/23: 0%->100

| ID | WBS | Task | Type | Duration | Start | Finish | Complete | Remaining | Total slack | Constraint | Resources | Work | Actual work | Acronym | PCG approved | WI rapporteur name | WI rapporteur e-mail | Release | TSG approved |
| --- | --- | --- | --- | --- | --- | --- | --- | --- | --- | --- | --- | --- | --- | --- | --- | --- | --- | --- | --- |
| 768 | 382 | **Stage-3 5GS NAS protocol development 18** |  | 399d | 2022-06-03 A | 2023-12-12 A | 100% |  |  |  |  | 6384h | 6384h | 5GProtoc18 | 49 | Sedlacek, Ivo, Ericsson, | ivo <dot> sedlacek <at> ericsson <dot> com | Rel-18 | 96 |
| 769 | 382.1 | Stage-3 5GS NAS protocol development 18 general aspects |  | 399d | 2022-06-03 A | 2023-12-12 A | 100% |  |  | finish no earlier than 2023-12-12 | C1 | 3192h | 3192h | 5GProtoc18 | 49 | Sedlacek, Ivo, Ericsson, | ivo <dot> sedlacek <at> ericsson <dot> com | Rel-18 | 96 |
| 770 | 382.2 | Stage-3 5GS NAS protocol development 18 non 3GPP aspects |  | 399d | 2022-06-03 A | 2023-12-12 A | 100% |  |  | finish no earlier than 2023-12-12 | C1 | 3192h | 3192h | 5GProtoc18-non3GPP | 49 | Sedlacek, Ivo, Ericsson, | ivo <dot> sedlacek <at> ericsson <dot> com | Rel-18 | 96 |
| 771 | 383 | **Stage-3 SAE Protocol Development** |  | 399d | 2022-06-03 A | 2023-12-12 A | 100% |  |  |  |  | 9576h | 9576h | SAES18 | 49 | Sethi, Anuj, InterDigital |  | Rel-18 | 96 |
| 772 | 383.1 | Stage-3 SAE Protocol Development general |  | 399d | 2022-06-03 A | 2023-12-12 A | 100% |  |  | finish no earlier than 2023-12-12 | C1 | 3192h | 3192h | SAES18 | 49 | Sethi, Anuj, InterDigital |  | Rel-18 | 96 |
| 773 | 383.2 | Stage-3 SAE Protocol Development CSFB |  | 399d | 2022-06-03 A | 2023-12-12 A | 100% |  |  | finish no earlier than 2023-12-12 | C1 | 3192h | 3192h | SAES18-CSFB | 49 | Sethi, Anuj, InterDigital |  | Rel-18 | 96 |
| 774 | 383.3 | Stage-3 SAE Protocol Development non 3GPP |  | 399d | 2022-06-03 A | 2023-12-12 A | 100% |  |  | finish no earlier than 2023-12-12 | C1 | 3192h | 3192h | SAES18-non3GPP | 49 | Sethi, Anuj, InterDigital |  | Rel-18 | 96 |
| 775 | 384 | **Protocol enhancements for Mission Critical Services** |  | 458d | 2022-06-03 A | 2024-03-03 A | 100% |  |  |  |  | 10984h | 10984h | MCProtoc18 | 49 | AXELL, Jörgen, Ericsson | jorgen.axell@ericsson.com | Rel-18 | 96 |
| 776 | 384.1 | CT1 aspects of MCProtoc18 |  | 458d | 2022-06-03 A | 2024-03-03 A | 100% |  |  | finish no earlier than 2024-03-03 | C1 | 3664h | 3664h | MCProtoc18 | 49 | Magnus Tränk, Ericsson | magnus.trank@ericsson.com | Rel-18 | 96 |
| 777 | 384.2 | CT3 aspects of MCProtoc18 |  | 457d | 2022-06-06 A | 2024-03-03 A | 100% |  |  | finish no earlier than 2024-03-03 | C3 | 3656h | 3656h | MCProtoc18 | 49 | Magnus Tränk, Ericsson | magnus.trank@ericsson.com | Rel-18 | 96 |
| 778 | 384.3 | CT4 aspects of MCProtoc18 |  | 458d | 2022-06-03 A | 2024-03-03 A | 100% |  |  | finish no earlier than 2024-03-03 | C4 | 3664h | 3664h | MCProtoc18 | 49 | Magnus Tränk, Ericsson | magnus.trank@ericsson.com | Rel-18 | 96 |
| 779 | 385 | MPS for Supplementary Services |  | 135d | 2022-06-03 A | 2022-12-08 A | 100% |  |  | finish no earlier than 2022-12-08 | C1 | 1080h | 1080h | MPSSupServ | 49 | Peter Monnes, Peraton Labs | pmonnes@peratonlabs.com | Rel-18 | 96 |
| 780 | 386 | **IMS Stage-3 IETF Protocol Alignment** |  | 399d | 2022-06-03 A | 2023-12-12 A | 100% |  |  |  |  | 6384h | 6384h | IMSProtoc18 | 49 | Won, Sung Hwan, Nokia | sung(dot)won(at)nokia(dot)com | Rel-18 | 96 |
| 781 | 386.1 | CT1 aspects of IMSProtoc18 |  | 399d | 2022-06-03 A | 2023-12-12 A | 100% |  |  | finish no earlier than 2023-12-12 | C1 | 3192h | 3192h | IMSProtoc18 | 49 | Won, Sung Hwan, Nokia | sung(dot)won(at)nokia(dot)com | Rel-18 | 97 |
| 782 | 386.2 | CT3 aspects of IMSProtoc18 |  | 399d | 2022-06-03 A | 2023-12-12 A | 100% |  |  | finish no earlier than 2023-12-12 | C3 | 3192h | 3192h | IMSProtoc18 | 49 | Won, Sung Hwan, Nokia | sung(dot)won(at)nokia(dot)com | Rel-18 | 97 |
| 783 | 387 | Enhancement of Shared Data ID and Handling |  | 522d | 2022-03-07 A | 2024-03-03 A | 100% |  |  | finish no earlier than 2024-03-03 | C4 | 4176h | 4176h | ShDatID_H | 49 | Jing, Hao, Huawei | hao.jing@huawei.com | Rel-18 | 96 |
| 784 | 388 | Rel-18 enhancements of session management policy control |  | 260d | 2022-12-15 A | 2023-12-12 A | 100% |  |  | start no earlier than 2022-12-15 | C3 | 2080h | 2080h | SMPC18 | 49 | Xiaoyun Zhou, Huawei | zhouxiaoyun8@huawei.com | Rel-18 | 96 |
| 785 | 389 | Enhancements on Service-based support for SMS in 5GC |  | 201d | 2023-03-13 A | 2023-12-15 A | 100% |  |  | finish no earlier than 2023-12-15 | C4 | 1608h | 1608h | eSMS_SBI | 49 | Liu, Liu, China Telecom | liuliu66@chinatelecom.cn | Rel-18 | 96 |
| 786 | 390 | Study on IMS Disaster Prevention and Restoration Enhancement |  | 399d | 2022-08-25 A | 2024-03-03 | 50% | 199.5d | 523d | finish no earlier than 2024-03-03 | C4 | 3192h |  | FS_IMS_RES | 49 | Liu, Liu, China Telecom | liuliu66@chinatelecom.cn | Rel-18 | 96 |
| 787 | 391 | **Modified PRINS for roaming service providers in 5G** |  | 25d | 2023-08-08 A | 2023-09-09 A | 100% |  |  |  | S1 | 600h | 600h | Roaming5G | 51 | Targali, Yousif, Verizon | yousif.targali@verizon.com | Rel-18 | 101 |
| 788 | 391.1 | Stage 1 of Roaming5G |  | 25d | 2023-08-08 A | 2023-09-09 A | 100% |  |  | start no earlier than 2023-08-08 | S1 | 200h | 200h | Roaming5G | 51 | Targali, Yousif, Verizon | yousif.targali@verizon.com | Rel-18 | 101 |
| 789 | 391.2 | Stage 3 of Roaming5G |  | 25d | 2023-08-08 A | 2023-09-09 A | 100% |  |  | start no earlier than 2023-08-08 | S3 | 200h | 200h | Roaming5G | 51 | Targali, Yousif, Verizon | yousif.targali@verizon.com | Rel-18 | 101 |
| 790 | 392 | NRF API enhancements to avoid signalling and storing of redundant data |  | 71d | 2023-12-12 A | 2024-03-15 A | 100% |  |  | finish no earlier than 2024-03-15 | C4 | 560h | 560h | NRFe | 49 | Wiehe, Ulrich, Nokia | ulrich.wiehe@nokia.com | Rel-18 | 96 |
| 791 | 393 | Rel-18 Other Security aspects | milestone | 0d? | 2016-03-15 A | 2016-03-15 A | 100% |  |  | start no earlier than 2016-03-15 |  |  |  |  |  |  |  | Rel-18 |  |
| 792 | 394 | Security Assurance Specification for AKMA Anchor Function Function (AAnF) |  | 257d | 2022-03-10 A | 2023-03-03 A | 100% |  |  | finish no earlier than 2023-03-03 | S3 | 2056h | 2056h | SCAS_5G_AAnF | 48 | Xiaoting Huang, China Mobile | huangxiaoting@chinamobile.com | Rel-18 | 95 |
| 793 | 395 | 5G Security Assurance Specification (SCAS) for the Policy Control Function (PCF) |  | 195d | 2023-03-16 A | 2023-12-12 A | 100% |  |  | finish no earlier than 2023-12-12 | S3 | 1560h | 1560h | SCAS_5G_PCF | 50 | Andreas, Joerg, BSI Germany | joerg.andreas@bsi.bund.de | Rel-18 | 99 |
| 794 | 396 | IETF DTLS protocol profile for AKMA and GBA |  | 128d | 2022-12-09 A | 2023-06-06 A | 100% |  |  | finish no earlier than 2023-06-06 | S3 | 1024h | 1024h | AKMA_GBA_DTLS | 50 | Liu, yuze, ZTE | liu.yuze@zte.com.cn | Rel-18 | 98 |
| 795 | 397 | IETF OSCORE protocol profiles for GBA and AKMA |  | 197d | 2022-12-09 A | 2023-09-09 A | 100% |  |  | finish no earlier than 2023-09-09 | S3 | 1576h | 1576h | AKMA_GBA_OSCORE | 50 | Tsiatsis, Vlasios, Ericsson | vlasios.tsiatsis@ericsson.com | Rel-18 | 98 |
| 796 | 398 | SCAS for split-gNB product classes |  | 257d | 2022-03-10 A | 2023-03-03 A | 100% |  |  | finish no earlier than 2023-03-03 | S3 | 2056h | 2056h | SCAS_5G_split_gNB | 48 | Escott, Adrian, Qualcomm Incorporated | aescott@qti.qualcomm.com | Rel-18 | 95 |

Notes:
- 768: ; 6/6/23: Compl:30%->40% / Impacted TSs and TRs: 23.040; 23.041; 23.122; 24.007; 24.008; 24.011; 24.173; 24.229; 24.301; 24.302; 24.305; 24.341; 24.368; 24.501; 24.502; 24.526; 27.007
- 769: Impacted TSs and TRs: 23.040; 23.041; 23.122; 24.007; 24.008; 24.011; 24.173; 24.229; 24.301; 24.302; 24.305; 24.341; 24.368; 24.501; 24.502; 24.526; 27.007
- 770: Impacted TSs and TRs: 23.040; 23.041; 23.122; 24.007; 24.008; 24.011; 24.173; 24.229; 24.301; 24.302; 24.305; 24.341; 24.368; 24.501; 24.502; 24.526; 27.007
- 771: ; 6/6/23: Compl:30%->40% / Impacted TSs and TRs: 23.122; 24.008; 24.167; 24.229; 24.301; 24.302; 24.303; 24.304; 24.305; 24.312; 29.018; 29.118; 24.368
- 772: Impacted TSs and TRs: 23.122; 24.008; 24.167; 24.229; 24.301; 24.302; 24.303; 24.304; 24.305; 24.312; 29.018; 29.118; 24.368
- 773: Impacted TSs and TRs: 23.122; 24.008; 24.167; 24.229; 24.301; 24.302; 24.303; 24.304; 24.305; 24.312; 29.018; 29.118; 24.368
- 774: Impacted TSs and TRs: 23.122; 24.008; 24.167; 24.229; 24.301; 24.302; 24.303; 24.304; 24.305; 24.312; 29.018; 29.118; 24.368
- 775: ; 20/6/22: FCD:12/12/2023->08/12/2023Rapporteur: ->AXELL, Jörgen, EricssonRap eMail: ->jorgen.axell@ericsson.comList of Impacted TS & TR updated / Impacted TSs and TRs: 24.229; 24.281; 24.282; 24.379; 24.380; 24.481; 24.482; 24.483; 24.484; 24.581; 24.582; 29.379; 29.380; 29.582; 29.165; 29.283
- 776: ; 20/6/22: FCD:12/12/2023->08/12/2023Rapporteur: ->AXELL, Jörgen, EricssonRap eMail: ->jorgen.axell@ericsson.comList of Impacted TS & TR updated; 9/6/23: 30%->40 / Impacted TSs and TRs: 24.229; 24.281; 24.282; 24.379; 24.380; 24.481; 24.482; 24.483; 24.484; 24.581; 24.582; 29.379; 29.380; 29.582; 29.165; 29.283
- 777: ; 20/6/22: FCD:12/12/2023->08/12/2023Rapporteur: ->AXELL, Jörgen, EricssonRap eMail: ->jorgen.axell@ericsson.comList of Impacted TS & TR updated; 9/6/23: 10%->30 / Impacted TSs and TRs: 24.229; 24.281; 24.282; 24.379; 24.380; 24.481; 24.482; 24.483; 24.484; 24.581; 24.582; 29.379; 29.380; 29.582; 29.165; 29.283
- 778: ; 20/6/22: FCD:12/12/2023->08/12/2023Rapporteur: ->AXELL, Jörgen, EricssonRap eMail: ->jorgen.axell@ericsson.comList of Impacted TS & TR updated; 6/6/23: Compl:... / Impacted TSs and TRs: 24.229; 24.281; 24.282; 24.379; 24.380; 24.481; 24.482; 24.483; 24.484; 24.581; 24.582; 29.379; 29.380; 29.582; 29.165; 29.283
- 779: 20/6/22: FCD:12/12/2022->08/12/2022WID: C1-221271->CP-221271Rapporteur: Peter Monnes, Peraton Labs ->Peter Monnes, Peraton LabsRap eMail: pmonnes@peratonlabs.com ->pmonnes@peratonlabs.comList of Impacted TS & TR updated / Impacted TSs and TRs: 24.229; 24.173; 24.629; 24.605; 24.239; 24.604; 24.642
- 780: Impacted TSs and TRs: 23.218; 24.229; 24.930; 29.163; 29.165; 29.292
- 781: ; 6/6/23: Compl:30%->40% / Impacted TSs and TRs: 23.218; 24.229; 24.930; 29.163; 29.165; 29.292
- 782: 9/6/23: 30%->60 / Impacted TSs and TRs: 23.218; 24.229; 24.930; 29.163; 29.165; 29.292
- 783: ; 6/6/23: Compl:0%->40% / Impacted TSs and TRs: 29.503; 29.504; 29.505
- 784: ; 6/6/23: Compl:25%->60% / Impacted TSs and TRs: 29.512; 29.513; 29.514
- 785: ; 6/6/23: Compl:0%->50% / Impacted TSs and TRs: 23.540; 29.338; 29.329; 29.230
- 786: 21/9/23: 29.866 added; / Impacted TSs and TRs: 29.xxx; 29.866
- 787: 9/23: company-submitted WID, to be corrected / Impacted TSs and TRs: 22.261; 33.501
- 788: 9/23: company-submitted WID, to be corrected / Impacted TSs and TRs: 22.261
- 789: 9/23: company-submitted WID, to be corrected; 8/12/23: 100%->100 / Impacted TSs and TRs: 33.501
- 790: Impacted TSs and TRs: 29.510, 29.571, 29.504
- 791: -
- 792: ; 4/6/22: 0%->10; 13/7/22: 33.537 added;; 11/12/22: 10%->70; 17/3/23: 70%->90; 8/6/23: 90%->95; 15/3/24: 95%->100 / Impacted TSs and TRs: 33.926 ; 33.537
- 793: ; 31/3/23: 33.528 added;; 7/9/23: 0%->40; 7/9/23: FCD:09/09/2023->12/23; 15/3/24: 40%->100 / Impacted TSs and TRs: 33.926 ; 33.528
- 794: ; 8/6/23: 0%->90; 7/9/23: 90%->100 / Impacted TSs and TRs: 33.535; 33.220; 33.222
- 795: ; 8/6/23: 0%->80; 7/9/23: FCD:06/06/2023->/23; 15/3/24: 80%->100 / Impacted TSs and TRs: 33.535; 33.220; 33.222
- 796: ; 4/6/22: 0%->5; 13/7/22: 33.742 added;; 12/9/22: 5%->25; 11/12/22: 25%->60; 17/3/23: 60%->85; 17/3/23: 33.523 added;; 8/6/23: 85%->99; 15/3/24: 99%->100 / Impacted TSs and TRs: 33.926 ; 33.742; 33.523

| ID | WBS | Task | Type | Duration | Start | Finish | Complete | Remaining | Total slack | Constraint | Resources | Work | Actual work | Acronym | PCG approved | Impacted TSs and TRs | WI rapporteur name | WI rapporteur e-mail | Release | TSG approved | Status Report |
| --- | --- | --- | --- | --- | --- | --- | --- | --- | --- | --- | --- | --- | --- | --- | --- | --- | --- | --- | --- | --- | --- |
| 797 | 399 | **Home network triggered primary authentication** |  | 519d | 2022-03-10 A | 2024-03-03 A | 100% |  |  |  | S3 | 7776h | 7776h | HN_Auth | 50 | 33.501; 33.535 | He Li, Huawei | LIHE2@HUAWEI.COM | Rel-18 | 98 |  |
| 798 | 399.1 | Study of Security aspect of home network triggered primary authentication |  | 198d | 2022-03-10 A | 2022-12-12 A | 100% |  |  | finish no earlier than 2022-12-12 | S3 | 1584h | 1584h | FS_HN_Auth | 48 |  | He Li, Huawei | LIHE2@HUAWEI.COM | Rel-18 | 95 |  |
| 799 | 399.2 | Security aspects of home network triggered primary authentication |  | 128d | 2022-12-09 A | 2023-06-06 A | 100% |  |  | finish no earlier than 2023-06-06 | S3 | 1024h | 1024h | HN_Auth | 50 | 33.501; 33.535 | He Li, Huawei | LIHE2@HUAWEI.COM | Rel-18 | 98 |  |
| 800 | 399.3 | CT aspects of home network triggered primary authentication |  | 127d | 2023-09-09 A | 2024-03-03 A | 100% |  |  | finish no earlier than 2024-03-03 | C4 | 1016h | 1016h | HN_Auth | 50 | 29.503, 29.504, 29.505, 29.518 | Jing, Hao, Huawei | hao.jing@huawei.com | Rel-18 | 98 |  |
| 801 | 400 | Study on AKMA Phase 2 |  | 198d | 2022-03-10 A | 2022-12-12 A | 100% |  |  | finish no earlier than 2022-12-12 | S3 | 1584h | 1584h | FS_AKMA_Ph2 | 48 | 33.737 | Xiaoting Huang, China Mobile | huangxiaoting@chinamobile.com | Rel-18 | 95 |  |
| 802 | 401 | AKMA phase 2 |  | 128d | 2023-03-16 A | 2023-09-09 A | 100% |  |  | finish no earlier than 2023-09-09 | S3 | 1024h | 1024h | AKMA_Ph2 | 50 | 33.535 | Huang Xiaoting, China Mobile | huangxiaoting@chinamobile.com | Rel-18 | 99 |  |
| 803 | 402 | Study of privacy of identifiers over radio access |  | 320d | 2021-12-13 A | 2023-03-03 A | 100% |  |  | finish no earlier than 2023-03-03 | S3 | 2560h | 2560h | FS_Id_Prvc | 48 | 33.870 | Brusilovsky, Alec, Interdigital | alec.brusilovsky@interdigital.com | Rel-18 | 94 |  |
| 804 | 403 | Study on Security Impacts of Virtualisation |  | 1043d | 2018-12-13 A | 2022-12-09 A | 100% |  |  | finish no earlier than 2022-12-12 | S3 | 8344h | 8344h | FS_SIV | 42 |  | Alex Leadbeater, BT Plc | alex.leadbeater@bt.com | Rel-18 | 82 |  |
| 805 | 404 | Study on Zero Trust Security principles in mobile networks |  | 197d | 2022-06-02 A | 2023-03-03 A | 100% |  |  | finish no earlier than 2023-03-03 | S3 | 1576h | 1576h | FS_ZTS | 49 | 33.894 | Sheeba Backia Mary B, Lenovo | smary@lenovo.com | Rel-18 | 96 |  |
| 806 | 405 | Study of Security aspects on User Consent for 3GPP Services Phase 2 |  | 197d | 2022-06-02 A | 2023-03-03 A | 100% |  |  | finish no earlier than 2023-03-03 | S3 | 1576h | 1576h | FS_UC3S_Ph2 | 49 | 33.896 | Rong Wu, Huawei, | Raina.wu@huawei.com | Rel-18 | 96 |  |
| 807 | 406 | Security aspects on User Consent for 3GPP services Phase 2 |  | 27d | 2023-05-01 A | 2023-06-06 A | 100% |  |  | start no earlier than 2023-05-01 | S3 | 216h | 216h | UC3S_SEC_Ph2 | 51 | 33.501 | Rong Wu, Huawei Technologies, | Raina.wu@huawei.com | Rel-18 | 100 |  |
| 808 | 407 | Security Assurance Specification for 5G Phase 3 |  | 130d | 2023-09-06 A | 2024-03-03 A | 100% |  |  | finish no earlier than 2024-03-03 | S3 | 1040h | 1040h | SCAS_5G_Ph3 | 51 | 33.926 | Wu, Rong, Huawei Technologies Co., Ltd. | Raina.wu@huawei.com | Rel-18 | 101 |  |
| 809 | 408 | Rel-18 NR-only: topics other than band | milestone | 0d? | 2019-03-07 | 2019-03-07 |  |  | 1828d |  |  |  |  |  |  |  |  |  | Rel-18 |  |  |
| 810 | 409 | **NR demodulation performance evolution** |  | 586d | 2022-03-15 A | 2024-06-06 | 84% | 95.12d | 453d |  |  | 5776h | 1088h | NR_demod_enh3 | 48 |  | China Telecom |  | Rel-18 | 95 |  |
| 811 | 409.1 | Core part: NR demodulation performance evolution |  | 136d | 2023-06-07 A | 2023-12-12 A | 100% |  |  | finish no earlier than 2023-12-12 | R4 | 1088h | 1088h | NR_demod_enh3-Core | 51 |  | Jingzhou Wu, China Telecom | wujingzhou@chinatelecom.cn | Rel-18 | 100 | RP-233584 |
| 812 | 409.2 | Perf. part: NR demodulation performance evolution |  | 586d | 2022-03-15 A | 2024-06-06 | 80% | 117.2d | 453d | finish no earlier than 2024-06-06 | R4 | 4688h |  | NR_demod_enh3-Perf | 48 | 38.878 | Jingzhou Wu, China Telecom | wujingzhou@chinatelecom.cn | Rel-18 | 95 | RP-240348 |
| 813 | 410 | **NR channel raster enhancement** |  | 261d | 2023-03-06 A | 2024-03-01 | 95% | 13.04d | 524d |  | R4 | 4176h | 1983.66h | NR_channel_raster_enh | 50 |  | Ericsson |  | Rel-18 | 99 |  |
| 814 | 410.1 | Core part: NR channel raster enhancement |  | 261d | 2023-03-06 A | 2024-03-01 | 95% | 13.05d | 524d | finish no earlier than 2024-03-01 | R4 | 2088h |  | NR_channel_raster_enh-Core | 50 |  | Christian Bergljung, Ericsson | Christian.Bergljung@ericsson.com | Rel-18 | 99 | RP-233392 |
| 815 | 411 | **Rel-18 4Rx for NR bands for FWA (Fixed Wireless Access) UEs (<2.6GHz) and handheld UEs (1GHz to 2.6GHz)** |  | 320d | 2022-12-13 A | 2024-03-01 A | 100% |  |  |  |  | 5120h | 5120h | 4Rx_NR_bands_R18 | 50 |  | ZTE |  | Rel-18 | 98 |  |
| 816 | 411.1 | Core part: Rel-18 4Rx for NR bands for FWA (Fixed Wireless Access) UEs (<2.6GHz) and handheld UEs (1GHz to 2.6GHz) |  | 320d | 2022-12-13 A | 2024-03-01 A | 100% |  |  | finish no earlier than 2024-03-01 | R4 | 2560h | 2560h | 4Rx_NR_bands_R18-Core | 50 |  | Wubin, Zhou, ZTE | zhou.wubin@zte.com.cn | Rel-18 | 98 | RP-240252 |
| 817 | 411.2 | Stopped - Perf. part: Rel-18 4Rx for NR bands for FWA (Fixed Wireless Access) UEs (<2.6GHz) and handheld UEs (1GHz to 2.6GHz) |  | 320d | 2022-12-13 A | 2024-03-01 A | 100% |  |  | finish no earlier than 2024-03-01 | R4 | 2560h | 2560h | 4Rx_NR_bands_R18-Perf | 50 |  | Wubin, Zhou, ZTE | zhou.wubin@zte.com.cn | Rel-18 | 98 | RP-240252 |
| 818 | 412 | **High power UE (power class 1.5) for NR FR1 TDD single band** |  | 718d | 2022-09-12 A | 2025-06-06 | 57% | 307.58d | 192d |  |  | 9440h | 2624h | HPUE_NR_FR1_TDD_R18 | 49 |  | CMCC |  | Rel-18 | 97 |  |
| 819 | 412.1 | Core part: High power UE (power class 1.5) for NR FR1 TDD single band |  | 328d | 2022-09-12 A | 2023-12-12 A | 100% |  |  | finish no earlier than 2023-12-12 | R4 | 2624h | 2624h | HPUE_NR_FR1_TDD_R18-Core | 49 | 38.895 | Chunxia Guo, CMCC | guochunxia@chinamobile.com | Rel-18 | 97 | RP-233448 |
| 820 | 412.2 | Perf. part: High power UE (power class 1.5) for NR FR1 TDD single band |  | 327d | 2022-09-13 | 2023-12-12 |  |  | 582d | finish no earlier than 2023-12-12 | R4 | 2616h |  | HPUE_NR_FR1_TDD_R18-Perf | 49 |  | Chunxia Guo, CMCC | guochunxia@chinamobile.com | Rel-18 | 97 | RP-223053 |
| 821 | 412.3 | UE Conformance - High power UE (power class 1.5) for NR FR1 TDD single band |  | 525d | 2023-06-08 A | 2025-06-06 | 66% | 178.5d | 192d | finish no earlier than 2025-06-06 | R5 | 4200h |  | HPUE_NR_FR1_TDD_R18-UEConTest | 51 |  | Dan SONG (CMCC), Yuxin Hao (Huawei), CMCC, Huawei | songdan@chinamobile.com, haoyuxin@huawei.com | Rel-18 | 100 | RP-240150 |

Notes:
- 797: ; 15/3/24: 99%->100
- 798: 4/6/22: 0%->30; 12/9/22: 30%->60; 11/12/22: 60%->80; 17/3/23: 80%->100
- 799: ; 7/9/23: 0%->100
- 801: 4/6/22: 0%->15; 13/7/22: 33.737 added;; 12/9/22: 15%->35; 23/9/22: WID:SP-220327->SP-220991; 11/12/22: 35%->70; 17/3/23: 70%->80; 8/6/23: 80%->95; 15/3/24: 95%->100
- 802: ; 8/6/23: 0%->95; 15/3/24: 95%->100
- 803: 7/1/22: 33.870 added;; 12/3/22: 0%->5; 4/6/22: 5%->10; 12/9/22: 10%->12; 17/3/23: 12%->25; 8/6/23: 25%->40; 7/9/23: 40%->80; 15/3/24: 80%->100
- 804: 20/3/19: 0%->2¦20/3/19: 0%->2; 31/5/19: 2%->10; 13/9/19: FCD:19/09/2019->12/20; 13/9/19: 10%->12; 6/12/19: 12%->45; 6/12/19: FCD:12/12/2019->03/20; 25/03/20: Rel-16->Rel-17; 26/6/20: FCD:12/03/2020->12/20; 5/12/20: FCD:15/12/2020->03/20; 19/3/21: 45%-> ; 7/9/23: 62%->100
- 805: 13/7/22: 33.894 added; 17/8/22: WID:SP-220536->SP-220674; 12/9/22: 0%->6; 11/12/22: 6%->25; 17/3/23: 25%->30; 8/6/23: 30%->40; 7/9/23: 40%->100
- 806: 13/7/22: 33.896 added;; 12/9/22: 0%->10; 11/12/22: 10%->50; 17/3/23: 50%->100
- 807: ; 15/3/24: 0%->100
- 808: ; 8/12/23: 0%->10; 15/3/24: 10%->100
- 809: -
- 810: compare REL-16 NR_perf_enh, REL-17 NR_demod_enh2; no Core part; TR 38.8XX ; 29/3/23: WID:RP-220932->RP-230314; 6/10/23: WID:RP-230314->RP-232685; 2/1/24: WID:RP-232685->RP-233586
- 811: 6/9/23: Compl:0%->33%; Stat Rep: ->RP-232250; Rapporteur: China Telecom->Jingzhou Wu, China Telecom; Rap eMail: ->wujingzhou@chinatelecom.cn; ; 8/12/23: Compl:33%->100%; Stat Rep: RP-232250->RP-233584;
- 812: compare REL-16 NR_perf_enh, REL-17 NR_demod_enh2; no Core part; TR 38.8XX ; 20/6/22: FCD:15/12/2023->23/12/2022; Stat Rep: ->RP-221287; Rapporteur: China Telecom->Jingzhou Wu, China Telecom; Rap eMail: ->wujingzhou@chinatelecom.cn12/7/22: WID:RP-2...;...; 14/3/24: FCD:01/03/2024->06/06/2024; Compl:70%->80%; Stat Rep: RP-233584->RP-240348;
- 813: 2/1/24: WID:RP-230813->RP-234025
- 814: ; 7/6/23: Compl:0%->25%; ;...; 6/9/23: Compl:25%->50%; WID: RP-230813->RP-231469; Stat Rep: ->RP-231756; Rapporteur: Ericsson->Christian Bergljung, Ericsson; Rap eMail: ->Christian.Bergljung@ericsson.com; ; 8/12/23: FCD:12/12/2023->01/03/2024; Compl:50%->95%; Stat Rep: RP-231756->RP-233392;
- 815: 29/3/23: WID:RP-223541->RP-230137; 6/10/23: WID:RP-230137->RP-231844; 2/1/24: WID:RP-231844->RP-234004; 2/4/24: WID:RP-234004->RP-240251
- 816: 17/3/23: Compl:0%->30%; Stat Rep: ->RP-230138; Rapporteur: ZTE->Wubin, Zhou, ZTE; Rap eMail: ->zhou.wubin@zte.com.cn; 7/6/23: Compl:30%->35%; 6/9/23: Compl:35%->60%; WID: RP-230137->RP-231119; Stat Rep: RP-230138->RP-231845; ; 8/12/23: FCD:12/12/2023-...; 14/3/24: Compl:65%->100%; WID: RP-234004->RP-234003; Stat Rep: RP-232928->RP-240252;
- 817: 17/3/23: Compl:0%->30%; Stat Rep: ->RP-230138; Rapporteur: ZTE->Wubin, Zhou, ZTE; Rap eMail: ->zhou.wubin@zte.com.cn; 7/6/23: Compl:30%->35%; 6/9/23: Compl:35%->60%; WID: RP-230137->RP-231119; Stat Rep: RP-230138->RP-231845; ; 8/12/23: FCD:12/12/2023-...; 2/4/24: stopped at 65%
- 818: 9/1/23: WID:RP-222351->RP-223499
- 819: 9/12/22: FCD:12/12/2023->01/12/2023; Compl:0%->30%; Stat Rep: ->RP-223053; Rapporteur: CMCC->Chunxia Guo, CMCC; Rap eMail: ->guochunxia@chinamobile.com; 17/3/23: FCD:30/11/2023->12/12/2023; Stat Rep: RP-223053->RP-230280; 17/3/23: 38.895 added;; ;...;...; 8/12/23: Compl:67%->100%; Stat Rep: RP-232239->RP-233448;
- 820: 9/12/22: FCD:12/12/2023->01/12/2023; Stat Rep: ->RP-223053; Rapporteur: CMCC->Chunxia Guo, CMCC; Rap eMail: ->guochunxia@chinamobile.com;
- 821: 21/9/23: Compl:0%->29%; Stat Rep: ->RP-232245; Rapporteur: CMCC->Dan SONG (CMCC), Yuxin Hao (Huawei), CMCC, Huawei; Rap eMail: ->songdan@chinamobile.com, haoyuxin@huawei.com; ; 8/12/23: Compl:29%->35%; Stat Rep: RP-232245->RP-233416; ; 14/3/24: FCD:05/06/2025->06/06/2025; Compl:35%->66%; Stat Rep: RP-233416->RP-240150;

| ID | WBS | Task | Duration | Start | Finish | Complete | Remaining | Total slack | Constraint | Resources | Work | Actual work | Acronym | PCG approved | WI rapporteur name | Release | TSG approved | Impacted TSs and TRs | WI rapporteur e-mail | Status Report | TSG stopped |
| --- | --- | --- | --- | --- | --- | --- | --- | --- | --- | --- | --- | --- | --- | --- | --- | --- | --- | --- | --- | --- | --- |
| 822 | 413 | **High power UE (power class 2) for NR FR1 FDD single band** | 592d | 2022-09-12 A | 2024-12-12 | 66% | 199.51d | 318d |  |  | 10504h |  | HPUE_NR_FR1_FDD_R18 | 49 | China Unicom | Rel-18 | 97 |  |  |  |  |
| 823 | 413.1 | Core part: High power UE (power class 2) for NR FR1 FDD single band | 457d | 2022-09-12 A | 2024-06-06 | 90% | 45.7d | 453d | finish no earlier than 2024-06-06 | R4 | 3656h |  | HPUE_NR_FR1_FDD_R18-Core | 49 | Basaier Jialade, China Unicom | Rel-18 | 97 | 38.896 | basejld@chinaunicom.cn | RP-240119 |  |
| 824 | 413.2 | Perf. part: High power UE (power class 2) for NR FR1 FDD single band | 457d | 2022-09-12 A | 2024-06-06 | 90% | 45.7d | 453d | finish no earlier than 2024-06-06 | R4 | 3656h |  | HPUE_NR_FR1_FDD_R18-Perf | 49 | Basaier Jialade, China Unicom | Rel-18 | 97 |  | basejld@chinaunicom.cn | RP-240119 |  |
| 825 | 413.3 | UE Conformance - High power UE (power class 2) for NR FR1 FDD single band | 399d | 2023-06-08 A | 2024-12-12 | 12% | 351.12d | 318d | finish no earlier than 2024-12-12 | R5 | 3192h |  | HPUE_NR_FR1_FDD_R18-UEConTest | 51 | Shi，Yu, China Unicom | Rel-18 | 100 |  | shiyu19@chinaunicom.cn | RP-240051 |  |
| 826 | 414 | **High power UE (power class 1.5 or 2) for intra-band Carrier Aggregation combinations of a single NR FR1 TDD band** | 457d | 2022-09-12 A | 2024-06-06 | 92% | 37.2d | 453d |  |  | 6736h | 3080h | HPUE_NR_FR1_TDD_intra_CA_R18 | 49 | Huawei | Rel-18 | 97 |  |  |  |  |
| 827 | 414.1 | Core part: High power UE (power class 1.5 or 2) for intra-band Carrier Aggregation combinations of a single NR FR1 TDD band | 457d | 2022-09-12 A | 2024-06-06 | 85% | 68.55d | 453d | finish no earlier than 2024-06-06 | R4 | 3656h |  | HPUE_NR_FR1_TDD_intra_CA_R18-Core | 49 | Lingyu Kong, Huawei, HiSilicon | Rel-18 | 97 | 38.897 | konglingyu4@hisilicon.com | RP-240426 |  |
| 828 | 414.2 | Stopped - Perf. part: High power UE (power class 1.5 or 2) for intra-band Carrier Aggregation combinations of a single NR FR1 TDD band | 385d | 2022-09-13 A | 2024-03-01 A | 100% |  |  | finish no earlier than 2024-03-01 | R4 | 3080h | 3080h | HPUE_NR_FR1_TDD_intra_CA_R18-Perf | 49 | Lingyu Kong, Huawei, HiSilicon | Rel-18 | 97 |  | konglingyu4@hisilicon.com | RP-233204 | 102 |
| 829 | 415 | **Rel-18 High power UE (power class 1,5 and 2) for a single FR1 NR TDD band in UL of NR inter-band CA/DC combinations with/without NR SUL (supplementary uplink) with y bands downlink (y=2,3,4,5,6) and x bands uplink (x=1,2)** | 457d | 2022-09-12 A | 2024-06-06 | 45% | 251.35d | 453d |  |  | 7312h |  | HPUE_FR1_TDD_NR_CADC_SUL_R18 | 49 | China Telecom | Rel-18 | 97 |  |  |  |  |
| 830 | 415.1 | Core part: Rel-18 High power UE (power class 1,5 and 2) for a single FR1 NR TDD band in UL of NR inter-band CA/DC combinations with/without NR SUL (supplementary uplink) with y bands downlink (y=2,3,4,5,6) and x bands uplink (x=1,2) | 457d | 2022-09-12 A | 2024-06-06 | 90% | 45.7d | 453d | finish no earlier than 2024-06-06 | R4 | 3656h |  | HPUE_FR1_TDD_NR_CADC_SUL_R18-Core | 49 | Lei GAO, China Telecom | Rel-18 | 97 | 38.899 | gaol8@chinatelecom.cn | RP-240356 |  |
| 831 | 415.2 | Perf. part: Rel-18 High power UE (power class 1,5 and 2) for a single FR1 NR TDD band in UL of NR inter-band CA/DC combinations with/without NR SUL (supplementary uplink) with y bands downlink (y=2,3,4,5,6) and x bands uplink (x=1,2) | 457d | 2022-09-12 | 2024-06-06 |  |  | 453d | finish no earlier than 2024-06-06 | R4 | 3656h |  | HPUE_FR1_TDD_NR_CADC_SUL_R18-Perf | 49 | Lei GAO, China Telecom | Rel-18 | 97 |  | gaol8@chinatelecom.cn | RP-240356 |  |
| 832 | 416 | **Rel-18 High power UE (power class 2) for a single FR1 NR FDD band in UL of NR intra-band and inter-band CA/DC combinations with y bands downlink (y=1,2,3,4,5,6) and x bands uplink (x=1)** | 457d | 2022-09-12 A | 2024-06-06 | 89% | 49.55d | 453d |  |  | 6744h | 3088h | HPUE_FR1_FDD_NR_CADC_R18 | 49 | China Unicom | Rel-18 | 97 |  |  |  |  |
| 833 | 416.1 | Core part: Rel-18 High power UE (power class 2) for a single FR1 NR FDD band in UL of NR intra-band and inter-band CA/DC combinations with y bands downlink (y=1,2,3,4,5,6) and x bands uplink (x=1) | 457d | 2022-09-12 A | 2024-06-06 | 80% | 91.4d | 453d | finish no earlier than 2024-06-06 | R4 | 3656h |  | HPUE_FR1_FDD_NR_CADC_R18-Core | 49 | Basaier Jialade, China Unicom | Rel-18 | 97 | 38.85 | basejld@chinaunicom.cn | RP-240122 |  |
| 834 | 416.2 | Stopped - Perf. Part: Rel-18 High power UE (power class 2) for a single FR1 NR FDD band in UL of NR intra-band and inter-band CA/DC combinations with y bands downlink (y=1,2,3,4,5,6) and x bands uplink (x=1) | 386d | 2022-09-12 A | 2024-03-01 A | 100% |  |  | finish no earlier than 2024-03-01 | R4 | 3088h | 3088h | HPUE_FR1_FDD_NR_CADC_R18-Perf | 49 | Basaier Jialade, China Unicom | Rel-18 | 97 |  | basejld@chinaunicom.cn | RP-240122 | 102 |
| 835 | 417 | **Adding new channel bandwidth(s) support to existing NR bands** | 388d | 2022-09-08 A | 2024-03-01 A | 100% |  |  |  |  | 3104h | 3104h | NR_bands_R18_BWs | 49 | Ericsson | Rel-18 | 97 |  |  |  |  |
| 836 | 417.1 | Core part: Adding new channel bandwidth(s) support to existing NR bands | 388d | 2022-09-08 A | 2024-03-01 A | 100% |  |  | finish no earlier than 2024-03-01 | R4 | 3104h | 3104h | NR_bands_R18_BWs-Core | 49 | Dominique Everaere, Ericsson | Rel-18 | 97 |  | dominique.everaere@erisson.com | RP-240275 |  |
| 837 | 418 | **Enhancement of Multiple Input Multiple Output (MIMO) Over-the-Air (OTA) test methodology and requirement for NR UEs** | 459d | 2022-09-08 A | 2024-06-06 | 83% | 79.95d | 453d |  | R4 | 9968h | 3970.44h | NR_MIMO_OTA_enh | 49 | CAICT | Rel-18 | 97 | 38.761 |  |  |  |
| 838 | 418.1 | Core part: Enhancement of Multiple Input Multiple Output (MIMO) Over-the-Air (OTA) test methodology and requirement for NR UEs | 330d | 2022-09-08 A | 2023-12-12 A | 100% |  |  | finish no earlier than 2023-12-12 | R4 | 2640h | 2640h | NR_MIMO_OTA_enh-Core | 49 | Zhu, Siting, CAICT | Rel-18 | 97 |  | zhusiting@caict.ac.cn | RP-240406 |  |
| 839 | 418.2 | Perf. Part: Enhancement of Multiple Input Multiple Output (MIMO) Over-the-Air (OTA) test methodology and requirement for NR UEs | 457d | 2022-09-12 A | 2024-06-06 | 70% | 137.1d | 453d | finish no earlier than 2024-06-06 | R4 | 3656h |  | NR_MIMO_OTA_enh-Perf | 49 | Zhu, Siting, CAICT | Rel-18 | 97 |  | zhusiting@caict.ac.cn | RP-240406 |  |
| 840 | 419 | **Rel-18 NR Carrier Aggregation (CA) band combinations with two SUL cells** | 320d | 2022-12-13 A | 2024-03-01 A | 100% |  |  |  |  | 5120h | 5120h | NR_2SUL_cell_combos_R18 | 50 | CMCC | Rel-18 | 98 |  |  |  |  |
| 841 | 419.1 | Core part: Rel-18 NR Carrier Aggregation (CA) band combinations with two SUL cells | 320d | 2022-12-13 A | 2024-03-01 A | 100% |  |  | finish no earlier than 2024-03-01 | R4 | 2560h | 2560h | NR_2SUL_cell_combos_R18-Core | 50 | Xiaoran ZHANG, CMCC | Rel-18 | 98 | 38.718-00-02 | zhangxiaoran@chinamobile.com | RP-240159 |  |
| 842 | 419.2 | Stopped - Perf. part: Rel-18 NR Carrier Aggregation (CA) band combinations with two SUL cells | 320d | 2022-12-13 A | 2024-03-01 A | 100% |  |  | finish no earlier than 2024-03-01 | R4 | 2560h | 2560h | NR_2SUL_cell_combos_R18-Perf | 50 | Xiaoran ZHANG, CMCC | Rel-18 | 98 |  | zhangxiaoran@chinamobile.com | RP-233445 |  |
| 843 | 420 | **NR support for dedicated spectrum less than 5MHz for FR1** | 1048d | 2021-12-13 A | 2025-12-12 | 60% | 423.03d | 57d |  |  | 13120h | 4184h | NR_FR1_lessthan_5MHz_BW | 48 | Nokia | Rel-18 | 94 |  |  |  |  |
| 844 | 420.1 | Core part: NR support for dedicated spectrum less than 5MHz for FR1 | 523d | 2021-12-13 A | 2023-12-12 A | 100% |  |  | finish no earlier than 2023-12-12 | R4 | 4184h | 4184h | NR_FR1_lessthan_5MHz_BW-Core | 48 | Man Hung Ng, Nokia | Rel-18 | 94 |  | man_hung.ng@nokia.com | RP-232749 |  |
| 845 | 420.2 | Perf. part: NR support for dedicated spectrum less than 5MHz for FR1 | 650d | 2021-12-15 A | 2024-06-06 | 70% | 195d | 453d | finish no earlier than 2024-06-06 | R4 | 5200h |  | NR_FR1_lessthan_5MHz_BW-Perf | 48 | Man Hung Ng, Nokia | Rel-18 | 94 |  | man_hung.ng@nokia.com | RP-240063 |  |
| 846 | 420.3 | UE Conformance - NR support for dedicated spectrum less than 5MHz for FR1 | 467d | 2024-03-03 | 2025-12-12 |  |  | 57d | finish no earlier than 2025-12-12 | R5 | 3736h |  | NR_FR1_lessthan_5MHz_BW-UEConTest |  | Nokia | Rel-18 |  |  |  |  |  |

Notes:
- 822: 9/1/23: WID:RP-222625->RP-222967; 29/3/23: WID:RP-222967->RP-230352; 6/10/23: WID:RP-230352->RP-232216; 2/1/24: WID:RP-232216->RP-233031; 2/4/24: WID:RP-233031->RP-240120
- 823: 9/12/22: FCD:12/12/2023->01/12/2023; Compl:0%->10%; Stat Rep: ->RP-222965; Rapporteur: China Unicom->Basaier Jialade, China Unicom; Rap eMail: ->basejld@chinaunicom.cn; 17/3/23: FCD:30/11/2023->12/12/2023; Stat Rep: RP-222965->RP-230353; 17/3/23: ...;...; 14/3/24: FCD:01/03/2024->06/06/2024; Compl:80%->90%; Stat Rep: RP-233032->RP-240119;
- 824: 9/12/22: FCD:12/12/2023->01/12/2023; Compl:0%->10%; Stat Rep: ->RP-222965; Rapporteur: China Unicom->Basaier Jialade, China Unicom; Rap eMail: ->basejld@chinaunicom.cn; 17/3/23: FCD:30/11/2023->12/12/2023; Stat Rep: RP-222965->RP-230353; ;...; 6/9/23:...; 14/3/24: FCD:01/03/2024->06/06/2024; Compl:80%->90%; Stat Rep: RP-233032->RP-240119;
- 825: 6/9/23: Compl:0%->5%; Stat Rep: ->RP-231549; Rapporteur: China Unicom->Shi，Yu, China Unicom; Rap eMail: ->shiyu19@chinaunicom.cn; ; 8/12/23: Stat Rep: RP-231549->RP-232773; ; 2/1/24: WID:RP-230869->RP-232774; 14/3/24: FCD:05/06/2024->12/12/2024; Compl:5%->12%; Stat Rep: RP-232773->RP-240051;
- 826: 9/1/23: WID:RP-222647->RP-223356; 29/3/23: WID:RP-223356->RP-230479; 6/10/23: WID:RP-230479->RP-232377; 2/1/24: WID:RP-232377->RP-233975; 2/4/24: WID:RP-233975->RP-240428
- 827: 9/12/22: FCD:12/12/2023->01/12/2023; Compl:0%->20%; WID: RP-222647->RP- 222647; Stat Rep: ->RP-223355; Rapporteur: Huawei->Lingyu Kong, Huawei, HiSilicon; Rap eMail: ->konglingyu4@hisilicon.com; 17/3/23: FCD:30/11/2023->12/12/2023; Compl:20%->30%; W.....; 14/3/24: FCD:01/03/2024->06/06/2024; Compl:80%->85%; Stat Rep: RP-233204->RP-240426;
- 828: 9/12/22: FCD:12/12/2023->01/12/2023; WID: RP-222647->RP- 222647; Stat Rep: ->RP-223355; Rapporteur: Huawei->Lingyu Kong, Huawei, HiSilicon; Rap eMail: ->konglingyu4@hisilicon.com; 17/3/23: WID: RP-223356->RP- 223356; Stat Rep: RP-223355->RP-230478; ; ...; 2/1/24: Stopped at 80% at RAN#102
- 829: 9/1/23: WID:RP-222623->RP-223496; 29/3/23: WID:RP-223496->RP-230309; 6/10/23: WID:RP-230309->RP-232256; 2/1/24: WID:RP-232256->RP-233561; 2/4/24: WID:RP-233561->RP-240763
- 830: 9/12/22: FCD:12/12/2023->01/12/2023; Compl:0%->15%; Stat Rep: ->RP-222941; Rapporteur: China Telecom->Lei GAO, China Telecom; Rap eMail: ->gaol8@chinatelecom.cn; 17/3/23: FCD:30/11/2023->12/12/2023; Compl:15%->30%; Stat Rep: RP-222941->RP-230310; ...;...; 14/3/24: FCD:01/03/2024->06/06/2024; Compl:80%->90%; Stat Rep: RP-233562->RP-240356;
- 831: 9/12/22: FCD:12/12/2023->01/12/2022; Stat Rep: ->RP-222941; Rapporteur: China Telecom->Lei GAO, China Telecom; Rap eMail: ->gaol8@chinatelecom.cn; 17/3/23: FCD:01/12/2022->12/12/2023; Stat Rep: RP-222941->RP-230310; ;...; 6/9/23: WID: RP-230309->RP-23...; 14/3/24: FCD:03/03/2024->06/06/2024; Stat Rep: RP-233562->RP-240356;
- 832: 9/1/23: WID:RP-222626->RP-222968; 29/3/23: WID:RP-222968->RP-230354; 2/1/24: WID:RP-230354->RP-234017; 2/4/24: WID:RP-234017->RP-240123
- 833: 9/12/22: FCD:12/06/2023->01/12/2023; Compl:0%->10%; Stat Rep: ->RP-222966; Rapporteur: China Unicom->Basaier Jialade, China Unicom; Rap eMail: ->basejld@chinaunicom.cn; 17/3/23: FCD:30/11/2023->12/12/2023; Stat Rep: RP-222966->RP-230355; 17/3/23: ...;...; 14/3/24: FCD:01/03/2024->06/06/2024; Compl:30%->80%; Stat Rep: RP-233035->RP-240122;
- 834: 9/12/22: FCD:12/06/2023->01/12/2023; Compl:0%->10%; Stat Rep: ->RP-222966; Rapporteur: China Unicom->Basaier Jialade, China Unicom; Rap eMail: ->basejld@chinaunicom.cn; 17/3/23: FCD:30/11/2023->12/12/2023; Stat Rep: RP-222966->RP-230355; ;...; 6/9/23:...; 14/3/24: Stat Rep: RP-233035->RP-240122;
- 835: 9/1/23: WID:RP-222629->RP-222898; 29/3/23: WID:RP-222898->RP-230756; 6/10/23: WID:RP-230756->RP-231706; 2/1/24: WID:RP-231706->RP-232952
- 836: 9/12/22: FCD:10/12/2023->01/12/2023; Compl:0%->2%; Stat Rep: ->RP-222899; Rapporteur: Ericsson->Dominique Everaere, Ericsson; Rap eMail: ->dominique.everaere@erisson.com; 17/3/23: FCD:30/11/2023->12/12/2023; Compl:2%->5%; Stat Rep: RP-222899->RP-230.....; 14/3/24: Compl:70%->100%; Stat Rep: RP-232951->RP-240275;
- 837: 9/1/23: WID:RP-222668->RP-223509; 6/10/23: WID:RP-223509->RP-232679; 6/10/23: 38.761 added;; 2/1/24: WID:RP-232679->RP-233742; 2/4/24: WID:RP-233742->RP-240736
- 838: 9/12/22: FCD:10/12/2023->01/12/2023; Compl:0%->20%; Stat Rep: ->RP-223185; Rapporteur: CAICT->Zhu, Siting, CAICT; Rap eMail: ->zhusiting@caict.ac.cn; 17/3/23: FCD:30/11/2023->12/12/2023; Compl:20%->35%; Stat Rep: RP-223185->RP-230367; ...; 6/9/23: Com...; 14/3/24: Stat Rep: RP-233741->RP-240406;
- 839: 9/12/22: FCD:10/06/2024->01/06/2024; Stat Rep: ->RP-223185; Rapporteur: CAICT->Zhu, Siting, CAICT; Rap eMail: ->zhusiting@caict.ac.cn; 17/3/23: Stat Rep: RP-223185->RP-230367; ;...; 6/9/23: FCD:06/06/2023->06/06/2024; Compl:20%->30%; Stat Rep: RP-2303...; 14/3/24: FCD:05/06/2024->06/06/2024; Compl:50%->70%; Stat Rep: RP-233741->RP-240406;
- 840: 29/3/23: WID:RP-223553->RP-230719; 6/10/23: WID:RP-230719->RP-232688; 2/1/24: WID:RP-232688->RP-233446; 2/4/24: WID:RP-233446->RP-240796
- 841: 17/3/23: Compl:0%->10%; Stat Rep: ->RP-230298; Rapporteur: CMCC->Xiaoran ZHANG, CMCC; Rap eMail: ->zhangxiaoran@chinamobile.com; 17/3/23: 38.718-00-02 added;; 31/3/23: Stat Rep: RP-230298->RP-230718; ;...; 6/9/23: Compl:30%->50%; Stat Rep: RP-230718->...; 14/3/24: Compl:70%->100%; Stat Rep: RP-233445->RP-240159;
- 842: 17/3/23: FCD:12/12/2023->06/06/2024; Compl:0%->10%; Stat Rep: ->RP-230298; Rapporteur: CMCC->Xiaoran ZHANG, CMCC; Rap eMail: ->zhangxiaoran@chinamobile.com; 31/3/23: FCD:06/06/2024->12/12/2023; Stat Rep: RP-230298->RP-230718; ;...; 6/9/23: Compl:30%->...; 2/4/24: stopped at 70%
- 843: 5/4/22: WID:RP-213603->RP-220401; 23/9/22: WID:RP-220401->RP-222645; 29/3/23: WID:RP-222645->RP-230186; 6/10/23: WID:RP-230186->RP-231713; 2/1/24: WID:RP-231713->RP-234027
- 844: ; 22/3/22: Stat Rep: ->RP-220402 6/6/22: CD:12/12/2023->13/12/2022 6/6/22: Stat Rep: RP-220402->RP-221415; 20/6/22: FCD:13/12/2022->23/12/2022; Rapporteur: Nokia->Toni L hteensuo, Nokia; Rap eMail: ->toni.h.lahteensuo@nokia.com13/7/22: FCD:23/12/20...;...; 8/12/23: Compl:95%->100%; Stat Rep: RP-231712->RP-232749;
- 845: ; 22/3/22: CD:23/06/2023->12/06/2024; 22/3/22: Stat Rep: ->RP-220402 ; 6/6/22: CD:12/06/2024->24/06/2022 ; 6/6/22: Stat Rep: RP-220402->RP-221415; 20/6/22: Rapporteur: Nokia->Toni L hteensuo, Nokia; Rap eMail: ->toni.h.lahteensuo@nokia.com13/7/22: ...;...; 14/3/24: FCD:05/06/2024->06/06/2024; Compl:40%->70%; WID: RP-234027->RP-233963; Stat Rep: RP-232749->RP-240063;

| ID | WBS | Task | Duration | Start | Finish | Complete | Remaining | Total slack | Constraint | Resources | Work | Actual work | Acronym | PCG approved | WI rapporteur name | Release | TSG approved | WI rapporteur e-mail | Status Report | Impacted TSs and TRs |
| --- | --- | --- | --- | --- | --- | --- | --- | --- | --- | --- | --- | --- | --- | --- | --- | --- | --- | --- | --- | --- |
| 847 | 421 | **Enhancement of NR Dynamic Spectrum Sharing (DSS)** | 652d | 2021-12-13 A | 2024-06-06 | 89% | 72.26d | 453d |  |  | 9384h | 4184h | NR_DSS_enh | 48 | Ericsson | Rel-18 | 94 |  |  |  |
| 848 | 421.1 | Core part: Enhancement of NR Dynamic Spectrum Sharing (DSS) | 523d | 2021-12-13 A | 2023-12-12 A | 100% |  |  | finish no earlier than 2023-12-12 | R1 | 4184h | 4184h | NR_DSS_enh-Core | 48 | Ravikiran Nory, Ericsson | Rel-18 | 94 | ravikiran.nory@ericsson.com | RP-232956 |  |
| 849 | 421.2 | Perf. part: Enhancement of NR Dynamic Spectrum Sharing (DSS) | 650d | 2021-12-15 A | 2024-06-06 | 80% | 130d | 453d | finish no earlier than 2024-06-06 | R1 | 5200h |  | NR_DSS_enh-Perf | 48 | Ravikiran Nory, Ericsson | Rel-18 | 94 | ravikiran.nory@ericsson.com | RP-240107 |  |
| 850 | 422 | **Multi-carrier enhancements for NR** | 1048d | 2021-12-13 A | 2025-12-12 | 71% | 302.58d | 57d |  |  | 13120h | 4184h | NR_MC_enh | 48 | NTT DOCOMO | Rel-18 | 94 |  |  |  |
| 851 | 422.1 | Core part: Multi-carrier enhancements for NR | 523d | 2021-12-13 A | 2023-12-12 A | 100% |  |  | finish no earlier than 2023-12-12 | R1 | 4184h | 4184h | NR_MC_enh-Core | 48 | Hiroki Harada, NTT DOCOMO, INC. | Rel-18 | 94 | hiroki.harada.sv@nttdocomo.com | RP-240070 |  |
| 852 | 422.2 | Perf. part: Multi-carrier enhancements for NR | 650d | 2021-12-15 A | 2024-06-06 | 99% | 6.5d | 453d | finish no earlier than 2024-06-06 | R1 | 5200h |  | NR_MC_enh-Perf | 48 | Hiroki Harada, NTT DOCOMO, INC. | Rel-18 | 94 | hiroki.harada.sv@nttdocomo.com | RP-240070 |  |
| 853 | 422.3 | UE Conformance - Multi-carrier enhancements for NR | 467d | 2024-03-03 | 2025-12-12 |  |  | 57d | finish no earlier than 2025-12-12 | R5 | 3736h |  | NR_MC_enh-UEConTest |  | China Telecom | Rel-18 |  |  |  |  |
| 854 | 423 | **Further NR coverage enhancements** | 1048d | 2021-12-13 A | 2025-12-12 | 64% | 381.5d | 57d |  |  | 13120h | 4184h | NR_cov_enh2 | 48 | China Telecom | Rel-18 | 94 |  |  |  |
| 855 | 423.1 | Core part: Further NR coverage enhancements | 523d | 2021-12-13 A | 2023-12-12 A | 100% |  |  | finish no earlier than 2023-12-12 | R1 | 4184h | 4184h | NR_cov_enh2-Core | 48 | Nanxi LI, China Telecom | Rel-18 | 94 | linanxi@chinatelecom.cn | RP-233557 |  |
| 856 | 423.2 | Perf. part: Further NR coverage enhancements | 650d | 2021-12-15 A | 2024-06-06 | 80% | 130d | 453d | finish no earlier than 2024-06-06 | R1 | 5200h |  | NR_cov_enh2-Perf | 48 | Nanxi LI, China Telecom | Rel-18 | 94 | linanxi@chinatelecom.cn | RP-240347 |  |
| 857 | 423.3 | UE Conformance - Further NR coverage enhancements | 467d | 2024-03-03 | 2025-12-12 |  |  | 57d | finish no earlier than 2025-12-12 | R5 | 3736h |  | NR_cov_enh2-UEConTest |  | China Telecom | Rel-18 |  |  |  |  |
| 858 | 424 | **NR MIMO evolution for downlink and uplink** | 1048d | 2021-12-13 A | 2025-12-12 | 52% | 506.11d | 57d |  |  | 13120h | 4184h | NR_MIMO_evo_DL_UL | 48 | Samsung | Rel-18 | 94 |  |  |  |
| 859 | 424.1 | Core part: NR MIMO evolution for downlink and uplink | 523d | 2021-12-13 A | 2023-12-12 A | 100% |  |  | finish no earlier than 2023-12-12 | R1 | 4184h | 4184h | NR_MIMO_evo_DL_UL-Core | 48 | Eko Onggosanusi, Samsung | Rel-18 | 94 | eko.o@samsung.com | RP-232913 |  |
| 860 | 424.2 | Perf. part: NR MIMO evolution for downlink and uplink | 650d | 2021-12-15 A | 2024-06-06 | 50% | 325d | 453d | finish no earlier than 2024-06-06 | R1 | 5200h |  | NR_MIMO_evo_DL_UL-Perf | 48 | Eko Onggosanusi, Samsung | Rel-18 | 94 | eko.o@samsung.com | RP-240368 |  |
| 861 | 424.3 | UE Conformance - NR MIMO evolution for downlink and uplink | 467d | 2024-03-03 | 2025-12-12 |  |  | 57d | finish no earlier than 2025-12-12 | R5 | 3736h |  | NR_MIMO_evo_DL_UL-UEConTest |  | Samsung | Rel-18 |  |  |  |  |
| 862 | 425 | Study on evolution of NR duplex operation | 523d | 2021-12-13 A | 2023-12-12 A | 100% |  |  | finish no earlier than 2023-12-12 | R1 | 4184h | 4184h | FS_NR_duplex_evo | 48 | Fei WANG, CMCC | Rel-18 | 94 | wangfei@chinamobile.com | RP-233435 | 38.858 |
| 863 | 426 | **NR network-controlled repeaters** | 459d | 2022-09-08 A | 2024-06-06 | 89% | 50.62d | 453d |  |  | 9944h | 6288h | NR_netcon_repeater | 49 | ZTE | Rel-18 | 97 |  |  |  |
| 864 | 426.1 | Core part: NR network-controlled repeaters | 330d | 2022-09-08 A | 2023-12-12 A | 100% |  |  | finish no earlier than 2023-12-12 | R1 | 2640h | 2640h | NR_netcon_repeater-Core | 49 | Nan Zhang, ZTE | Rel-18 | 97 | Zhang.nan152@zte.com.cn | RP-240112 |  |
| 865 | 426.2 | Perf. part: NR network-controlled repeaters | 457d | 2022-09-12 A | 2024-06-06 | 70% | 137.1d | 453d | finish no earlier than 2024-06-06 | R1 | 3656h |  | NR_netcon_repeater-Perf | 49 | Nan Zhang, ZTE | Rel-18 | 97 | Zhang.nan152@zte.com.cn | RP-240112 |  |
| 866 | 426.3 | Study on NR network-controlled repeaters | 456d | 2022-09-08 A | 2024-06-06 A | 100% |  |  |  | R1 | 3648h | 3648h | FS_NR_netcon_repeater | 48 | Nan Zhang, ZTE | Rel-18 | 94 | Zhang.nan152@zte.com.cn | RP-221231 | 38.867 |
| 867 | 427 | **Further NR mobility enhancements** | 652d | 2021-12-13 A | 2024-06-06 | 66% | 223.78d | 453d |  |  | 9848h | 4648h | NR_Mob_enh2 | 48 | MediaTek | Rel-18 | 94 |  |  |  |
| 868 | 427.1 | Core part: Further NR mobility enhancements | 581d | 2021-12-13 A | 2024-03-01 A | 100% |  |  | finish no earlier than 2024-03-01 | R2 | 4648h | 4648h | NR_Mob_enh2-Core | 48 | Li-Chuan Tseng, MediaTek Inc. | Rel-18 | 94 | li-chuan.tseng@mediatek.com | RP-240443 |  |
| 869 | 427.2 | Perf. part: Further NR mobility enhancements | 650d | 2021-12-15 A | 2024-06-06 | 35% | 422.5d | 453d | finish no earlier than 2024-06-06 | R2 | 5200h |  | NR_Mob_enh2-Perf | 48 | Li-Chuan Tseng, MediaTek Inc. | Rel-18 | 94 | li-chuan.tseng@mediatek.com | RP-240443 |  |
| 870 | 428 | **In-Device Co-existence (IDC) enhancements for NR and MR-DC** | 523d | 2021-12-13 A | 2023-12-12 A | 100% |  |  |  |  | 4184h | 4184h | NR_IDC_enh | 48 | Xiaomi | Rel-18 | 94 |  |  |  |
| 871 | 428.1 | Core part: In-Device Co-existence (IDC) enhancements for NR and MR-DC | 523d | 2021-12-13 A | 2023-12-12 A | 100% |  |  | finish no earlier than 2023-12-12 | R2 | 4184h | 4184h | NR_IDC_enh-Core | 48 | Yumin Wu, Xiaomi | Rel-18 | 94 | wuyumin@xiaomi.com | RP-233484 |  |

Notes:
- 847: compare REL-17 WI NR_DSS-Core; 12/7/22: WID:RP-213575->RP-221622; 2/1/24: WID:RP-221622->RP-232957
- 848: compare REL-17 WI NR_DSS-Core; 22/3/22: Stat Rep: ->RP-220589 ; 6/6/22: Compl:0%->40% ; 20/6/22: Rapporteur: Ericsson->Ravikiran Nory, Ericsson; Rap eMail: ->ravikiran.nory@ericsson.com13/7/22: FCD:23/12/2022->12/20 ; ...; 9/12/22: FCD:23/12/2022->01...; 8/12/23: Compl:95%->100%; Stat Rep: RP-232132->RP-232956;
- 849: ; 22/3/22: CD:24/06/2024->12/06/2024; 22/3/22: Stat Rep: ->RP-220589 ; 6/6/22: CD:12/06/2024->24/06/2022 ; 6/6/22: Stat Rep: RP-220589->RP-221621; 20/6/22: WG: R4->R1; Rapporteur: Ericsson->Ravikiran Nory, Ericsson; Rap eMail: ->ravikiran.nory@ericsson...; 14/3/24: FCD:05/06/2024->06/06/2024; Compl:60%->80%; Stat Rep: RP-232956->RP-240107;
- 850: 5/4/22: WID:RP-213577->RP-220834; 12/7/22: WID:RP-220834->RP-221435; 23/9/22: WID:RP-221435->RP-222251; 2/1/24: WID:RP-222251->RP-234012
- 851: ; 22/3/22: CD:23/06/2023->12/06/2023; 22/3/22: Stat Rep: ->RP-220616 ; 6/6/22: Compl:0%->10% 20/6/22: Rapporteur: NTT DOCOMO->Hiroki Harada, NTT DOCOMO, INC.; Rap eMail: ->hiroki.harada@docomo-lab.com13/7/22: FCD:23/12/2022->12/20 ...; 23/9/22: WID:RP-...; 14/3/24: WID: RP-234012->RP-222251; Stat Rep: RP-233545->RP-240070;
- 852: ; 22/3/22: Stat Rep: ->RP-220616 6/6/22: CD:12/12/2023->24/06/2022 6/6/22: Stat Rep: RP-220616->RP-221436; 20/6/22: WG: R4->R1; Rapporteur: NTT DOCOMO->Hiroki Harada, NTT DOCOMO, INC.; Rap eMail: ->hiroki.harada@docomo-lab.com13/7/22: FCD:24/06/2...;...; 2/4/24: WID:RP-222251->RP-240321
- 854: compare REL-17 WI NR_cov_enh; 5/4/22: WID:RP-213579->RP-220937; 12/7/22: WID:RP-220937->RP-221858; 2/1/24: WID:RP-221858->RP-233558
- 855: compare REL-17 WI NR_cov_enh; 22/3/22: Stat Rep: ->RP-220566 ; 6/6/22: CD:12/12/2023->23/12/2022 ; 6/6/22: WID: RP-220937->RP- 220937 ; 6/6/22: Stat Rep: RP-220566->RP-221282; 20/6/22: Rapporteur: China Telecom->Nanxi LI, China Telecom; Rap eMail: ->li...; 8/12/23: Compl:85%->100%; Stat Rep: RP-232272->RP-233557;
- 856: ; 22/3/22: CD:24/06/2024->12/06/2024; 22/3/22: Stat Rep: ->RP-220566 6/6/22: CD:12/06/2024->24/06/2022 6/6/22: WID: RP-220937->RP- 220937 6/6/22: Stat Rep: RP-220566->RP-221282; 20/6/22: WG: R4->R1; Rapporteur: China Telecom->Nanxi LI, China Telecom; R...; 14/3/24: FCD:05/06/2024->06/06/2024; Compl:60%->80%; Stat Rep: RP-233557->RP-240347;
- 858: compare REL-16 WI NR_eMIMO and REL-17 WI NR_feMIMO; 9/1/23: WID:RP-213598->RP-223276; 2/1/24: WID:RP-223276->RP-233028
- 859: compare REL-16 WI NR_eMIMO and REL-17 WI NR_feMIMO; 22/3/22: Stat Rep: ->RP-220669 6/6/22: Compl:0%->10% 20/6/22: Rapporteur: Samsung->Eko Onggosanusi, Samsung; Rap eMail: ->eko.o@samsung.com13/7/22: FCD:23/12/2022->12/20 ;...; 9/12/22: FCD:23/12/202...; 8/12/23: Compl:90%->100%; Stat Rep: RP-231717->RP-232913;
- 860: ; 22/3/22: CD:24/06/2024->12/06/2024; 22/3/22: Stat Rep: ->RP-220669 6/6/22: CD:12/06/2024->24/06/2022 6/6/22: Stat Rep: RP-220669->RP-221393; 20/6/22: WG: R4->R1; Rapporteur: Samsung->Eko Onggosanusi, Samsung; Rap eMail: ->eko.o@samsung.com13/7/...;...; 14/3/24: FCD:05/06/2024->06/06/2024; Compl:25%->50%; Stat Rep: RP-232913->RP-240368;
- 862: 21/1/22: 38.858 added;; 22/3/22: Stat Rep: ->RP-220632; 5/4/22: WID:RP-213591->RP-220633 6/6/22: Compl:0%->10% 20/6/22: Rapporteur: CMCC->Fei WANG, CMCC; Rap eMail: ->wangfei@chinamobile.com12/7/22: WID:RP-220633->RP-221352; 13/7/22: FCD:23/12...; 23/...; 8/12/23: Compl:94%->100%; Stat Rep: RP-232231->RP-233435;
- 863: 9/1/23: WID:RP-222673->RP-223505; 29/3/23: WID:RP-223505->RP-230175; 2/1/24: WID:RP-230175->RP-232886
- 864: 9/12/22: FCD:10/12/2023->01/12/2023; Compl:0%->80%; Stat Rep: ->RP-222874; Rapporteur: ZTE->Nan Zhang, ZTE; Rap eMail: ->Zhang.nan152@zte.com.cn; 17/3/23: FCD:30/11/2023->12/12/2023; Compl:80%->90%; WID: RP-222673->RP-223505; Stat Rep: RP-222874->RP.....; 14/3/24: Stat Rep: RP-232854->RP-240112;
- 865: 9/12/22: WG: R4->R1; FCD:10/06/2024->01/06/2024; Stat Rep: ->RP-222874; Rapporteur: ZTE->Nan Zhang, ZTE; Rap eMail: ->Zhang.nan152@zte.com.cn; 17/3/23: WID: RP-222673->RP-223505; Stat Rep: RP-222874->RP-230174; ...; 6/9/23: FCD:06/06/2023->06/06/2024;...; 14/3/24: FCD:05/06/2024->06/06/2024; Compl:50%->70%; Stat Rep: RP-232854->RP-240112;
- 866: compare REL-17 WI NR_repeaters; TR 38.8xx; 21/1/22: 38.867 added;; 22/3/22: Stat Rep: ->RP-220214 6/6/22: Compl:0%->40% ; 20/6/22: Rapporteur: ZTE->Nan Zhang, ZTE; Rap eMail: ->Zhang.nan152@zte.com.cn12/7/22: WID:RP-213700->RP-221229 ;...; 23/9/22: 0%->100
- 867: compare REL-16 WI NR_Mob_enh; 12/7/22: WID:RP-213565->RP-221799; 23/9/22: WID:RP-221799->RP-222332; 9/1/23: WID:RP-222332->RP-223520; 2/1/24: WID:RP-223520->RP-233970
- 868: compare REL-16 WI NR_Mob_enh; 22/3/22: CD:12/12/2023->12/09/2023; 22/3/22: Stat Rep: ->RP-220760 6/6/22: CD:12/09/2023->23/09/2022 6/6/22: Stat Re ; 20/6/22: Acronym:NR_Mob_enh2-Core->NR_mob_enh2-Core; Rapporteur: MediaTek->Li-Chuan Tseng, MediaTek Inc...; 14/3/24: Compl:95%->100%; Stat Rep: RP-233251->RP-240443;
- 869: ; 22/3/22: CD:24/06/2024->12/12/2023; 22/3/22: Stat Rep: ->RP-220760 ; 6/6/22: CD:12/12/2023->23/12/2022 ; 6/6/22: Stat Rep: RP-220760->RP-221557; 20/6/22: Acronym:NR_Mob_enh2-Perf->NR_mob_enh2-Perf; WG: R4->R2; Rapporteur: MediaTek->Li-Chuan Tseng, Me...; 14/3/24: FCD:05/06/2024->06/06/2024; Compl:10%->35%; Stat Rep: RP-233251->RP-240443;
- 870: MR-DC: Multi-RAT Dual Connectivity; no Perf. part; 12/7/22: WID:RP-213589->RP-221281; 2/1/24: WID:RP-221281->RP-233485
- 871: MR-DC: Multi-RAT Dual Connectivity; no Perf. part; 20/6/22: Acronym:NR_IDC_enh-Core->NR_IDC_Enh-Core; FCD:12/12/2023->23/12/2022; Stat Rep: ->RP-221280; Rapporteur: Xiaomi->Yumin Wu, Xiaomi; Rap eMail: ->wuyumin@xiaomi.com13/7/22: FCD:23/12/2022->1...;...; 8/12/23: Compl:99%->100%; Stat Rep: RP-232631->RP-233484;

| ID | WBS | Task | Duration | Start | Finish | Complete | Remaining | Total slack | Constraint | Resources | Work | Actual work | Acronym | PCG approved | Release | TSG approved | WI rapporteur e-mail | Status Report | Impacted TSs and TRs |
| --- | --- | --- | --- | --- | --- | --- | --- | --- | --- | --- | --- | --- | --- | --- | --- | --- | --- | --- | --- |
| 872 | 429 | **BS/UE EMC enhancements for NR and LTE** | 457d | 2022-03-15 A | 2023-12-12 A | 100% |  |  |  |  | 7312h | 7312h | NR_LTE_EMC_enh | 48 | Rel-18 | 95 |  |  |  |
| 873 | 429.1 | Core part: BS/UE EMC enhancements for NR and LTE | 457d | 2022-03-15 A | 2023-12-12 A | 100% |  |  | finish no earlier than 2023-12-12 | R4 | 3656h | 3656h | NR_LTE_EMC_enh-Core | 48 | Rel-18 | 95 | Aurelian.Bria@ericsson.com | RP-233683 |  |
| 874 | 429.2 | Perf. part: BS/UE EMC enhancements for NR and LTE | 457d | 2022-03-15 A | 2023-12-12 A | 100% |  |  | finish no earlier than 2023-12-12 | R4 | 3656h | 3656h | NR_LTE_EMC_enh-Perf | 48 | Rel-18 | 95 | Aurelian.Bria@ericsson.com | RP-233683 |  |
| 875 | 430 | **Air-to-ground network for NR** | 847d | 2022-03-15 A | 2025-06-06 | 86% | 121.36d | 192d |  |  | 10888h | 7768h | NR_ATG | 48 | Rel-18 | 95 |  |  |  |
| 876 | 430.1 | Core part: Air-to-ground network for NR | 457d | 2022-03-15 A | 2023-12-12 A | 100% |  |  | finish no earlier than 2023-12-12 | R4 | 3656h | 3656h | NR_ATG-Core | 48 | Rel-18 | 95 | guochunxia@chinamobile.com | RP-240158 |  |
| 877 | 430.2 | Perf. part: Air-to-ground network for NR | 514d | 2022-03-16 A | 2024-03-01 A | 100% |  |  | finish no earlier than 2024-03-01 | R4 | 4112h | 4112h | NR_ATG-Perf | 48 | Rel-18 | 95 | guochunxia@chinamobile.com | RP-240158 |  |
| 878 | 430.3 | UE Conformance - Air-to-ground network for NR | 390d | 2023-12-13 A | 2025-06-06 | 50% | 195d | 192d | finish no earlier than 2025-06-06 | R5 | 3120h |  | NR_ATG-UEConTest | 52 | Rel-18 | 102 | songdan@chinamobile.com | RP-240148 |  |
| 879 | 431 | **NR RF requirements enhancement for frequency range 2 (FR2), Phase 3** | 778d | 2022-03-15 A | 2025-03-03 | 72% | 214.34d | 261d |  |  | 9880h | 3656h | NR_RF_FR2_req_Ph3 | 48 | Rel-18 | 95 |  |  |  |
| 880 | 431.1 | Core part: NR RF requirements enhancement for frequency range 2 (FR2), Phase 3 | 457d | 2022-03-15 A | 2023-12-12 A | 100% |  |  | finish no earlier than 2023-12-12 | R4 | 3656h | 3656h | NR_RF_FR2_req_Ph3-Core | 48 | Rel-18 | 95 | hisashi.onozawa@nokia.com zhangjuan8@xiaomi.com | RP-232790 | 38.891 |
| 881 | 431.2 | Perf. part: NR RF requirements enhancement for frequency range 2 (FR2), Phase 3 | 515d | 2022-03-15 A | 2024-03-01 | 85% | 77.25d | 524d | finish no earlier than 2024-03-01 | R4 | 4120h |  | NR_RF_FR2_req_Ph3-Perf | 48 | Rel-18 | 95 | hisashi.onozawa@nokia.com zhangjuan8@xiaomi.com | RP-232790 |  |
| 882 | 431.3 | UE Conformance - NR RF requirements enhancement for frequency range 2 (FR2), Phase 3 | 263d | 2024-03-03 | 2025-03-03 |  |  | 261d | finish no earlier than 2025-03-03 | R5 | 2104h |  | NR_RF_FR2_req_Ph3-UEConTest |  | Rel-18 |  |  |  |  |
| 883 | 432 | **Requirement for NR frequency range 2 (FR2) multi-Rx chain DL reception** | 449d | 2022-03-15 A | 2023-11-30 | 92% | 35.68d |  |  |  | 7776h | 3656h | NR_FR2_multiRX_DL | 48 | Rel-18 | 95 | binhan@qti.qualcomm.com | RP-223153 |  |
| 884 | 432.1 | Core part: Requirement for NR frequency range 2 (FR2) multi-Rx chain DL reception | 457d | 2022-03-15 A | 2023-12-12 A | 100% |  |  | finish no earlier than 2023-12-12 | R4 | 3656h | 3656h | NR_FR2_multiRX_DL-Core | 48 | Rel-18 | 95 | sumanti@qti.qualcomm.com | RP-240297 | 38.751 |
| 885 | 432.2 | Perf. part: Requirement for NR frequency range 2 (FR2) multi-Rx chain DL reception | 515d | 2022-03-15 A | 2024-03-01 | 85% | 77.25d | 524d | finish no earlier than 2024-03-01 | R4 | 4120h |  | NR_FR2_multiRX_DL-Perf | 48 | Rel-18 | 95 | sumanti@qti.qualcomm.com | RP-240297 |  |
| 886 | 433 | **Even Further RRM enhancement for NR and MR-DC** | 586d | 2022-03-15 A | 2024-06-06 | 72% | 164.37d | 453d |  |  | 8328h | 3656h | NR_RRM_enh3 | 48 | Rel-18 | 95 |  |  |  |
| 887 | 433.1 | Core part: Even Further RRM enhancement for NR and MR-DC | 457d | 2022-03-15 A | 2023-12-12 A | 100% |  |  | finish no earlier than 2023-12-12 | R4 | 3656h | 3656h | NR_RRM_enh3-Core | 48 | Rel-18 | 95 | jie_cui@apple.com | RP-240490 |  |
| 888 | 433.2 | Perf. part: Even Further RRM enhancement for NR and MR-DC | 584d | 2022-03-17 A | 2024-06-06 | 50% | 292d | 453d | finish no earlier than 2024-06-06 | R4 | 4672h |  | NR_RRM_enh3-Perf | 48 | Rel-18 | 95 | jie_cui@apple.com | RP-240490 |  |
| 889 | 434 | **Further RF requirements enhancement for NR and EN-DC in frequency range 1 (FR1)** | 847d | 2022-03-15 A | 2025-06-06 | 72% | 240.6d | 192d |  |  | 11000h | 3656h | NR_ENDC_RF_FR1_enh2 | 48 | Rel-18 | 95 |  |  |  |
| 890 | 434.1 | Core part: Further RF requirements enhancement for NR and EN-DC in frequency range 1 (FR1) | 457d | 2022-03-15 A | 2023-12-12 A | 100% |  |  | finish no earlier than 2023-12-12 | R4 | 3656h | 3656h | NR_ENDC_RF_FR1_enh2-Core | 48 | Rel-18 | 95 | leo.liuye@huawei.com yuuta.oguma.yt@nttdocomo.com | RP-233185 | 38.881 |
| 891 | 434.2 | Perf. part: Further RF requirements enhancement for NR and EN-DC in frequency range 1 (FR1) | 586d | 2022-03-15 A | 2024-06-06 | 90% | 58.6d | 453d | finish no earlier than 2024-06-06 | R4 | 4688h |  | NR_ENDC_RF_FR1_enh2-Perf | 48 | Rel-18 | 95 | leo.liuye@huawei.com yuuta.oguma.yt@nttdocomo.com | RP-240411 |  |
| 892 | 434.3 | UE Conformance - Further RF requirements enhancement for NR and EN-DC in frequency range 1 | 332d | 2024-03-03 | 2025-06-06 |  |  | 192d | finish no earlier than 2025-06-06 | R5 | 2656h |  | NR_ENDC_RF_FR1_enh2-UEConTest |  | Rel-18 |  |  |  |  |
| 893 | 435 | **Support of intra-band non-collocated EN-DC/NR-CA deployment** | 457d | 2022-03-15 A | 2023-12-12 | 97% | 11.43d | 582d |  |  | 7304h | 3648h | NonCol_intraB_ENDC_NR_CA | 48 | Rel-18 | 95 |  |  |  |
| 894 | 435.1 | Core part: Support of intra-band non-collocated EN-DC/NR-CA deployment | 457d | 2022-03-15 A | 2023-12-12 | 95% | 22.85d | 582d | finish no earlier than 2023-12-12 | R4 | 3656h |  | NonCol_intraB_ENDC_NR_CA-Core | 48 | Rel-18 | 95 | ui-suzuki@kddi.com | RP-232113 |  |
| 895 | 435.2 | Perf. part: Support of intra-band non-collocated EN-DC/NR-CA deployment | 456d | 2022-03-16 A | 2023-12-12 A | 100% |  |  | finish no earlier than 2023-12-12 | R4 | 3648h | 3648h | NonCol_intraB_ENDC_NR_CA-Perf | 48 | Rel-18 | 95 | ui-suzuki@kddi.com | RP-232113 |  |

Notes:
- 872: compare REL-15 WI AASenh_BS_LTE_UTRA ; 2/1/24: WID:RP-220916->RP-233976 / WI rapporteur name: Ericsson
- 873: compare REL-15 WI AASenh_BS_LTE_UTRA ; 6/6/22: CD:15/06/2023->23/09/2022 ; 6/6/22: Stat Rep: ->RP-221165; 20/6/22: Rapporteur: Ericsson->Aurelian Bria, Ericsson; Rap eMail: ->aurelian.bria@ericsson.com13/7/22: FCD:23/09/2022->09/20 ;...; 9/12/22: FCD...; 8/12/23: Compl:95%->100%; Stat Rep: RP-232637->RP-233683; / WI rapporteur name: Aurelian Bria, Ericsson
- 874: compare REL-15 WI AASenh_BS_LTE_UTRA 6/6/22: CD:15/12/2023->23/12/2022 6/6/22: Stat Rep: ->RP-221165; 20/6/22: Rapporteur: Ericsson->Aurelian Bria, Ericsson; Rap eMail: ->aurelian.bria@ericsson.com13/7/22: FCD:23/12/2022->12/20...; 9/12/22: FCD:23/12...; 8/12/23: Compl:80%->100%; Stat Rep: RP-232637->RP-233683; / WI rapporteur name: Aurelian Bria, Ericsson
- 875: TR 38.8xx ; 12/7/22: WID:RP-220962->RP-221369; 29/3/23: WID:RP-221369->RP-230279; 2/1/24: WID:RP-230279->RP-234023; 2/4/24: WID:RP-234023->RP-240732 / WI rapporteur name: CMCC
- 876: TR 38.8xx 6/6/22: CD:15/12/2023->23/12/20226/6/22: Stat Rep: ->RP-221370; 20/6/22: Rapporteur: CMCC->Shao Zhe, CMCC; Rap eMail: ->Shaozhe@chinamobile.com13/7/22: FCD:23/12/2022->12/20 ...; 9/12/22: FCD:23/12/2022->01/12/2023; Compl:5%->20%; Stat Rep...; 14/3/24: Stat Rep: RP-233443->RP-240158; / WI rapporteur name: Guo Chunxia, CMCC
- 877: 6/6/22: CD:15/03/2024->24/03/2023 6/6/22: Stat Rep: ->RP-221370; 20/6/22: Rapporteur: CMCC->Shao Zhe, CMCC; Rap eMail: ->Shaozhe@chinamobile.com13/7/22: FCD:24/03/2023->03/20 ;...; 9/12/22: FCD:24/03/2023->01/03/2024; Stat Rep: RP-221370->RP-2230...; 14/3/24: Compl:80%->100%; Stat Rep: RP-233443->RP-240158; / WI rapporteur name: Guo Chunxia, CMCC
- 878: 14/3/24: Compl:0%->50%; Stat Rep: ->RP-240148; Rapporteur: CMCC->Dan SONG, CMCC; Rap eMail: ->songdan@chinamobile.com; ; 2/4/24: WID:RP-233412->RP-240750. corrected: Rel-19->Rel-18 / WI rapporteur name: Dan SONG, CMCC
- 879: compare REL-16 WI NR_RF_FR2_req_enh and REL-17 WI NR_RF_FR2_req_enh2 ; 12/7/22: WID:RP-220967->RP-221862; 23/9/22: WID:RP-221862->RP-222228; 9/1/23: WID:RP-222228->RP-222909; 2/1/24: WID:RP-222909->RP-232791 / WI rapporteur name: Nokia
- 880: compare REL-16 WI NR_RF_FR2_req_enh and REL-17 WI NR_RF_FR2_req_enh2 6/6/22: CD:15/12/2023->23/12/2022 6/6/22: Stat Rep: ; 20/6/22: Rapporteur: Nokia->Vasenkari, Petri, Nokia; Rap eMail: ->Petri.j.vasenkari@nokia.com13/7/22: FCD:23/12/2022->12/20...;...; 8/12/23: Compl:75%->100%; Stat Rep: RP-232607->RP-232790; / WI rapporteur name: Primary: Hisashi Onozawa Secondary: Juan Zhang, Nokia Xiaomi
- 881: ; 6/6/22: CD:15/03/2024->24/03/2023 ; 6/6/22: Stat Rep: ->RP-221207; 20/6/22: Rapporteur: Nokia->Vasenkari, Petri, Nokia; Rap eMail: ->Petri.j.vasenkari@nokia.com13/7/22: FCD:24/03/2023->03/20 ; ;...; 9/12/22: FCD:24/03/2023->01/03/2024; Compl:10%...; 8/12/23: Compl:75%->85%; Stat Rep: RP-232607->RP-232790; / WI rapporteur name: Primary: Hisashi Onozawa Secondary: Juan Zhang, Nokia Xiaomi
- 882: WI rapporteur name: Apple
- 883: ; 12/7/22: WID:RP-220974->RP-221753; 9/12/22: Acronym:NR_FR2_multiRX_DL->FS_NR_FR2_OTA_enh; FCD:01/03/2024->01/12/2023; Compl:11%->25%; WID: RP-221753->RP-222652; Stat Rep: ->RP-223153; Rapporteur: Qualcomm->Bin Han, Qualcomm Incorporated; Rap eMail:...; 2/1/24: WID:RP-231714->RP-234020 / WI rapporteur name: Bin Han, Qualcomm Incorporated
- 884: 6/6/22: CD:15/09/2023->23/09/2022 6/6/22: WID: RP-220974->R4-220974 6/6/22: Stat Rep: ->RP-221225; 20/6/22: Stat Rep: RP-221225->RP-221225 / 1752; Rapporteur: Qualcomm->Sumant Iyer, Qualcomm Inc.; Rap eMail: ->sumanti@qti.qualcomm.com13/7/22: FC...;...; 14/3/24: WID: RP-234020->RP-233076; Stat Rep: RP-233077->RP-240297; / WI rapporteur name: Sumant Iyer, Qualcomm Inc.
- 885: 6/6/22: CD:15/03/2024->24/09/2022 6/6/22: WID: RP-220974->R4-220974 6/6/22: Stat Rep: ->RP-221225; 20/6/22: FCD:24/09/2022->24/03/2023; Stat Rep: RP-221225->RP-221225 / 1752; Rapporteur: Qualcomm->Sumant Iyer, Qualcomm Inc.; Rap eMail: ->sumanti@qt...; 2/4/24: WID:RP-240296->RP-234020 / WI rapporteur name: Sumant Iyer, Qualcomm Inc.
- 886: compare REL-16 WI NR_RRM_enh and REL-17 WI NR_RRM_enh2; RAN1/2 impact to be checked ; 12/7/22: WID:RP-220977->RP-221696; 2/1/24: WID:RP-221696->RP-233496 / WI rapporteur name: Apple
- 887: compare REL-16 WI NR_RRM_enh and REL-17 WI NR_RRM_enh2; RAN1/2 impact to be checked ; 20/6/22: FCD:15/12/2023->23/12/2022; Stat Rep: ->RP-221697; Rapporteur: Apple->Jie Cui, Apple; Rap eMail: ->jie_cui@apple.com13/7/22: FCD:23/12/2022->12/20; ...; 9/1...; 14/3/24: WID: RP-233496->RP-221696; Stat Rep: RP-233494->RP-240490; / WI rapporteur name: Jie Cui, Apple
- 888: 6/6/22: CD:15/06/2024->24/06/2022 6/6/22: Stat Rep: ->RP-221697; 20/6/22: Rapporteur: Apple->Jie Cui, Apple; Rap eMail: ->jie_cui@apple.com13/7/22: FCD:24/06/2022->06/20 ; ...; 9/12/22: FCD:24/06/2023->01/06/2024; WID: RP-220977->RP-221696; Stat ...; 14/3/24: FCD:05/06/2024->06/06/2024; Compl:10%->50%; WID: RP-233496->RP-221696; Stat Rep: RP-233494->RP-240490; / WI rapporteur name: Jie Cui, Apple
- 889: compare REL-16 WI NR_RF_FR1 and REL-17 WI NR_RF_FR1_enh ; 12/7/22: WID:RP-220987->RP-221496; 9/1/23: WID:RP-221496->RP-223478; 29/3/23: WID:RP-223478->RP-230753; 6/10/23: WID:RP-230753->RP-232366; 2/1/24: WID:RP-232366->RP-233186 / WI rapporteur name: Huawei
- 890: compare REL-16 WI NR_RF_FR1 and REL-17 WI NR_RF_FR1_enh 6/6/22: CD:15/12/2023->23/12/2022 6/6/22: Stat Rep: ->RP-221495; 20/6/22: Rapporteur: Huawei->Liu Ye, Huawei, HiSilicon; Rap eMail: ->leo.liuye@huawei.com13/7/22: FCD:23/12/2022->12/20; 13/7...;...; 8/12/23: Compl:80%->100%; Stat Rep: RP-232365->RP-233185; / WI rapporteur name: Primary: Ye Liu Secondary: Yuta Oguma, Huawei NTT DOCOMO, INC.
- 891: ; 6/6/22: CD:15/06/2024->24/06/2022 ; 6/6/22: Stat Rep: ->RP-221495; 20/6/22: Rapporteur: Huawei->Liu Ye, Huawei, HiSilicon; Rap eMail: ->leo.liuye@huawei.com13/7/22: FCD:24/06/2022->06/20 ; ;...; 9/12/22: FCD:23/06/2023->31/05/2024; Compl:10%->20...; 14/3/24: FCD:05/06/2024->06/06/2024; Compl:85%->90%; WID: RP-233186->RP-232366; Stat Rep: RP-233185->RP-240411; / WI rapporteur name: Primary: Ye Liu Secondary: Yuta Oguma, Huawei NTT DOCOMO, INC.
- 892: WI rapporteur name: Huawei
- 893: ; 12/7/22: WID:RP-221012->RP-221809; 23/9/22: WID:RP-221809->RP-222309; 29/3/23: WID:RP-222309->RP-230742; 2/1/24: WID:RP-230742->RP-233513 / WI rapporteur name: KDDI
- 894: ; 20/6/22: FCD:15/09/2023->23/09/2022; Stat Rep: ->RP-221742; Rapporteur: KDDI->Yasuki Suzuki; Rap eMail: ->ui-suzuki@kddi.com13/7/22: FCD:23/09/2022->09/20 ...; 9/12/22: FCD:23/09/2022->01/09/2023; Compl:10%->20%; Stat Rep: RP-221742->RP-222956;...; 6/9/23: FCD:09/09/2023->12/12/2023; Compl:92%->95%; WID: RP-230742->RP-231066; Stat Rep: RP-230461->RP-232113; / WI rapporteur name: Yasuki Suzuki, KDDI
- 895: ; 20/6/22: FCD:15/12/2023->23/12/2022; Stat Rep: ->RP-221742; Rapporteur: KDDI->Yasuki Suzuki; Rap eMail: ->ui-suzuki@kddi.com13/7/22: FCD:23/12/2022->12/20 ...; 9/12/22: FCD:23/12/2022->01/12/2023; Stat Rep: RP-221742->RP-222956; Rapporteur: Yas...; 2/4/24: 70%->100 / WI rapporteur name: Yasuki Suzuki, KDDI

| ID | WBS | Task | Type | Duration | Start | Finish | Complete | Remaining | Total slack | Constraint | Resources | Work | Actual work | Acronym | PCG approved | Release | TSG approved | WI rapporteur e-mail | Status Report | TSG stopped |
| --- | --- | --- | --- | --- | --- | --- | --- | --- | --- | --- | --- | --- | --- | --- | --- | --- | --- | --- | --- | --- |
| 896 | 436 | **Further enhancements on NR and MR-DC measurement gaps and measurements without gaps** |  | 586d | 2022-03-15 A | 2024-06-06 | 72% | 163.74d | 453d |  |  | 11464h | 3656h | NR_MG_enh2 | 48 | Rel-18 | 95 |  |  |  |
| 897 | 436.1 | Core part: Further enhancements on NR and MR-DC measurement gaps and measurements without gaps |  | 457d | 2022-03-15 A | 2023-12-12 A | 100% |  |  | finish no earlier than 2023-12-12 | R4 | 3656h | 3656h | NR_MG_enh2-Core | 48 | Rel-18 | 95 | ato.yu@mediatek.com, meng.zhang@intel.com | RP-240445 |  |
| 898 | 436.2 | Perf. part: Further enhancements on NR and MR-DC measurement gaps and measurements without gaps |  | 586d | 2022-03-15 A | 2024-06-06 | 35% | 380.9d | 453d | finish no earlier than 2024-06-06 | R4 | 4688h |  | NR_MG_enh2-Perf | 48 | Rel-18 | 95 | ato.yu@mediatek.com, meng.zhang@intel.com | RP-240445 |  |
| 899 | 436.3 | UE Conformance - NR and MR-DC measurement gap enhancements |  | 390d | 2022-12-14 A | 2024-06-06 | 95% | 19.5d | 453d | finish no earlier than 2024-06-06 | R5 | 3120h |  | NR_MG_enh-UEConTest | 50 | Rel-17 | 98 | daiwei.zhou@mediatek.com | RP-240441 |  |
| 900 | 437 | **Dual Transmission/Reception (Tx/Rx) Multi-SIM for NR** |  | 913d | 2021-12-13 A | 2025-06-06 | 48% | 470.25d | 192d |  | R2 | 18832h | 5869.23h | NR_DualTxRx_MUSIM | 48 | Rel-18 | 94 |  |  |  |
| 901 | 437.1 | Core part: Dual Transmission/Reception (Tx/Rx) Multi-SIM for NR |  | 523d | 2021-12-13 A | 2023-12-12 A | 100% |  |  | finish no earlier than 2023-12-12 | R2 | 4184h | 4184h | NR_DualTxRx_MUSIM-Core | 48 | Rel-18 | 94 | Yangxiaodong5g@vivo.com | RP-233070 |  |
| 902 | 437.2 | Perf. Part: Dual Transmission/Reception (Tx/Rx) Multi-SIM for NR |  | 586d | 2022-03-15 A | 2024-06-06 | 30% | 410.2d | 453d | finish no earlier than 2024-06-06 | R2 | 4688h |  | NR_DualTxRx_MUSIM-Perf | 48 | Rel-18 | 95 | Yangxiaodong5g@vivo.com | RP-240136 |  |
| 903 | 437.3 | UE Conformance - Dual Transmission/Reception (Tx/Rx) Multi-SIM for NR |  | 332d | 2024-03-03 | 2025-06-06 |  |  | 192d | finish no earlier than 2025-06-06 | R5 | 2656h |  | NR_DualTxRx_MUSIM-UEConTest |  | Rel-18 |  |  |  |  |
| 904 | 438 | Rel-18 NR-only: band related | milestone | 0d? | 2019-03-07 | 2019-03-07 |  |  | 1828d |  |  |  |  |  |  | Rel-18 |  |  |  |  |
| 905 | 439 | **Addition of FDD NR bands using the uplink from n28 and the downlink of n75 and n76** |  | 203d | 2023-03-06 A | 2023-12-12 | 99% | 0d | 0d |  | R4 | 4872h | 3481.93h | NR_FDD_ULn28_DLn75_n76 | 50 | Rel-18 | 99 |  |  |  |
| 906 | 439.1 | Core part: Addition of FDD NR bands using the uplink from n28 and the downlink of n75 and n76 |  | 203d | 2023-03-06 A | 2023-12-12 A | 100% |  |  | finish no earlier than 2023-12-12 | R4 | 1624h | 1624h | NR_FDD_ULn28_DLn75_n76-Core | 50 | Rel-18 | 99 | Wael.boukleyhasan@vodafone.com | RP- 233244 |  |
| 907 | 439.2 | Perf. part: Addition of FDD NR bands using the uplink from n28 and the downlink of n75 and n76 |  | 203d | 2023-03-06 A | 2023-12-12 A | 100% |  |  | finish no earlier than 2023-12-12 | R4 | 1624h | 1624h | NR_FDD_ULn28_DLn75_n76-Perf | 50 | Rel-18 | 99 | Wael.boukleyhasan@vodafone.com | RP- 233244 |  |
| 908 | 440 | **Complete the specification support for BandWidth Part operation without restriction in NR** |  | 332d | 2023-03-06 A | 2024-06-06 | 54% | 154.16d | 453d |  | R4 | 6920h | 2027.36h | NR_BWP_wor | 50 | Rel-18 | 99 |  |  |  |
| 909 | 440.1 | Core part: Complete the specification support for BandWidth Part operation without restriction in NR |  | 203d | 2023-03-06 A | 2023-12-12 A | 100% |  |  | finish no earlier than 2023-12-12 | R4 | 1624h | 1624h | NR_BWP_wor-Core | 50 | Rel-18 | 99 | diogo.martins@vodafone.com | RP-240385 |  |
| 910 | 440.2 | Perf. part: Complete the specification support for BandWidth Part operation without restriction in NR |  | 330d | 2023-03-08 A | 2024-06-06 | 25% | 247.5d | 453d | finish no earlier than 2024-06-06 | R4 | 2640h |  | NR_BWP_wor-Perf | 50 | Rel-18 | 99 | diogo.martins@vodafone.com | RP-240385 |  |
| 911 | 441 | **Introduction of NR bands n31 and n72** |  | 68d | 2023-09-09 A | 2023-12-12 | 99% | 0d | 0d |  | R4 | 1632h | 1491.88h | NR_bands_n31_n72 | 51 | Rel-18 | 101 |  |  |  |
| 912 | 441.1 | Core part: Introduction of NR bands n31 and n72 |  | 68d | 2023-09-09 A | 2023-12-12 A | 100% |  |  | finish no earlier than 2023-12-12 | R4 | 544h | 544h | NR_bands_n31_n72-Core | 51 | Rel-18 | 101 | petri.j.vasenkari@nokia.com | RP-233181 |  |
| 913 | 441.2 | Perf. part: Introduction of NR bands n31 and n72 |  | 68d | 2023-09-09 A | 2023-12-12 A | 100% |  |  | finish no earlier than 2023-12-12 | R4 | 544h | 544h | NR_bands_n31_n72-Perf | 51 | Rel-18 | 101 | petri.j.vasenkari@nokia.com | RP-233181 |  |
| 914 | 442 | **Enhancement for 700/800/900MHz band combinations for NR** |  | 203d | 2023-03-06 A | 2023-12-12 A | 100% |  |  |  | R4 | 4872h | 4872h | NR_700800900_combo_enh | 50 | Rel-18 | 99 |  |  |  |
| 915 | 442.1 | Core part: Enhancement for 700/800/900MHz band combinations for NR |  | 203d | 2023-03-06 A | 2023-12-12 A | 100% |  |  | finish no earlier than 2023-12-12 | R4 | 1624h | 1624h | NR_700800900_combo_enh-Core | 50 | Rel-18 | 99 | shanhuiping@catt.cn | RP-233005 |  |
| 916 | 442.2 | Stopped - Perf. part: Enhancement for 700/800/900MHz band combinations for NR |  | 203d | 2023-03-06 A | 2023-12-12 A | 100% |  |  | finish no earlier than 2023-12-12 | R4 | 1624h | 1624h | NR_700800900_combo_enh-Perf | 50 | Rel-18 | 99 | shanhuiping@catt.cn | RP-231833 | 102 |
| 917 | 443 | **Introduction of NR TDD band in 1670-1675 MHz (n54)** |  | 60d | 2022-12-12 A | 2023-03-03 A | 100% |  |  |  |  | 960h | 960h | NR_TDD_n54 | 50 | Rel-18 | 98 |  |  |  |
| 918 | 443.1 | Core part: Introduction of NR TDD band in 1670-1675 MHz (n54) |  | 60d | 2022-12-12 A | 2023-03-03 A | 100% |  |  | finish no earlier than 2023-03-03 | R4 | 480h | 480h | NR_TDD_n54-Core | 50 | Rel-18 | 98 | ojas.choksi@ligado.com | RP-230061 |  |
| 919 | 443.2 | Perf. part: Introduction of NR TDD band in 1670-1675 MHz (n54) |  | 60d | 2022-12-12 A | 2023-03-03 A | 100% |  |  | finish no earlier than 2023-03-03 | R4 | 480h | 480h | NR_TDD_n54-Perf | 50 | Rel-18 | 98 | ojas.choksi@ligado.com | RP-230061 |  |

Notes:
- 896: compare REL-14 WI LTE_meas_gap_enh and REL-17 WI NR_MG_enh ; 5/4/22: WID:RP-221018 ->RP-220772; 23/9/22: WID:RP-220772->RP-222337; 29/3/23: WID:RP-222337->RP-230755; 6/10/23: WID:RP-230755->RP-232440; 2/1/24: WID:RP-232440->RP-234021 / WI rapporteur name: MediaTek
- 897: compare REL-14 WI LTE_meas_gap_enh and REL-17 WI NR_MG_enh ; 20/6/22: FCD:15/12/2023->23/12/2022; WID: RP-220772->RP-221018; Stat Rep: ->RP-221560; Rapporteur: MediaTek->Ato (Tsang-Wei) YU, Rui HUANG, MediaTek Inc., Intel Corporation; Rap eMail: ->ato...; 14/3/24: WID: RP-234021->RP-232440; Stat Rep: RP-233256->RP-240445; / WI rapporteur name: Tsang-Wei (Ato) YU, Meng ZHANG, MediaTek Inc., Intel Corporation
- 898: ; 6/6/22: CD:15/06/2024->24/06/2022 ; 6/6/22: WID: RP-220772->RP-221018 ; 6/6/22: Stat Rep: ->RP-221560; 20/6/22: Rapporteur: MediaTek->Ato (Tsang-Wei) YU, Rui HUANG, MediaTek Inc., Intel Corporation; Rap eMail: ->ato.yu@mediatek.com, rui.huang@int...; 14/3/24: FCD:05/06/2024->06/06/2024; Compl:10%->35%; WID: RP-234021->RP-232440; Stat Rep: RP-233256->RP-240445; / WI rapporteur name: Tsang-Wei (Ato) YU, Meng ZHANG, MediaTek Inc., Intel Corporation
- 899: 17/3/23: FCD:03/03/2024->01/03/2024; Compl:0%->31%; Stat Rep: ->RP-230638; Rapporteur: MediaTek->Daiwei Zhou, MediaTek Inc.; Rap eMail: ->daiwei.zhou@mediatek.com; ;...; 6/9/23: Compl:55%->63%; Stat Rep: RP-230638->RP-232306; ; 8/12/23: FCD:03/03/2024...; 14/3/24: FCD:01/03/2024->06/06/2024; Compl:90%->95%; Stat Rep: RP-233248->RP-240441; / WI rapporteur name: Daiwei Zhou, MediaTek Inc.
- 900: compare REL-17 WI LTE_NR_MUSIM-Core; no Perf. part; 5/4/22: WID:RP-213584->RP-220955; 9/1/23: WID:RP-220955->RP-223492; 29/3/23: WID:RP-223492->RP-230751; 2/1/24: WID:RP-230751->RP-233071 / WI rapporteur name: vivo
- 901: 6/6/22: CD:12/09/2023->23/12/2022 6/6/22: Stat Rep: ->RP-221273; 20/6/22: Rapporteur: vivo->Xiaodong Yang, vivo; Rap eMail: ->Yangxiaodong5g@vivo.com13/7/22: FCD:23/12/2022->12/20 ...; 9/12/22: FCD:23/12/2022->01/12/2023; Compl:5%->20%; Stat Rep: RP...; 8/12/23: Compl:65%->100%; Stat Rep: RP-231817->RP-233070; / WI rapporteur name: Xiaodong Yang, vivo
- 902: 20/6/22: WG: R4->R2; FCD:14/06/2024->24/06/2022; Stat Rep: ->RP-221273; Rapporteur: vivo->Xiaodong Yang, vivo; Rap eMail: ->Yangxiaodong5g@vivo.com13/7/22: FCD:24/06/2022->06/20 ;...; 17/3/23: FCD:06/06/2023->06/06/2024; Stat Rep: RP-221273->RP-2303...; 14/3/24: FCD:05/06/2024->06/06/2024; Compl:10%->30%; WID: RP-233071->RP-231461; Stat Rep: RP-233070->RP-240136; / WI rapporteur name: Xiaodong Yang, vivo
- 903: WI rapporteur name: China Telecom
- 904: -
- 905: 6/10/23: WID:RP-230791->RP-232636; 2/1/24: WID:RP-232636->RP-233245 / WI rapporteur name: Vodafone
- 906: ; 7/6/23: Compl:0%->43%; 6/9/23: FCD:09/09/2023->22/09/2023; Compl:43%->80%; WID: RP-230791->RP-231476; Stat Rep: ->RP-231747; Rapporteur: Vodafone->Wael Boukley Hasan, Vodafone; Rap eMail: ->Wael.boukleyhasan@vodafone.com; ; 21/9/23: FCD:22/09/2023->1...; 8/12/23: Compl:80%->100%; Stat Rep: RP-232630->RP- 233244; / WI rapporteur name: Wael Boukley Hasan, Vodafone
- 907: 6/9/23: FCD:09/09/2023->23/09/2023; WID: RP-230791->RP-231476; Stat Rep: ->RP-231747; Rapporteur: Vodafone->Wael Boukley Hasan, Vodafone; Rap eMail: ->Wael.boukleyhasan@vodafone.com; ; 21/9/23: FCD:23/09/2023->12/12/2023; Stat Rep: RP-231747->RP-232630; ; 8/12/23: Compl:0%->100%; Stat Rep: RP-232630->RP- 233244; / WI rapporteur name: Wael Boukley Hasan, Vodafone
- 908: 6/10/23: WID:RP-230805->RP-232677; 2/1/24: WID:RP-232677->RP-233999 / WI rapporteur name: Vodafone
- 909: ; 7/6/23: Compl:0%->40%; 6/9/23: Compl:40%->60%; WID: RP-230805->RP-231486; Stat Rep: ->RP-231924; Rapporteur: Vodafone->Diogo Martins, Vodafone; Rap eMail: ->diogo.martins@vodafone.com; ; 8/12/23: Compl:60%->100%; Stat Rep: RP-231924->RP-233039; ; 14/3/24: WID: RP-233999->RP-232677; Stat Rep: RP-233039->RP-240385; / WI rapporteur name: Diogo Martins, Vodafone
- 910: ; 7/6/23: CD:06/06/2024->06/06/2023; 6/9/23: FCD:06/06/2023->06/06/2024; WID: RP-230805->RP-231486; Stat Rep: ->RP-231924; Rapporteur: Vodafone->Diogo Martins, Vodafone; Rap eMail: ->diogo.martins@vodafone.com; ; 8/12/23: Stat Rep: RP-231924->RP-233039; ; 14/3/24: Compl:0%->25%; WID: RP-233999->RP-232677; Stat Rep: RP-233039->RP-240385; / WI rapporteur name: Diogo Martins, Vodafone
- 911: 2/1/24: WID:RP-232691->RP-233950 / WI rapporteur name: Nokia
- 912: 8/12/23: Compl:0%->100%; Stat Rep: ->RP-233181; Rapporteur: Nokia->Petri Vasenkari, Nokia; Rap eMail: ->petri.j.vasenkari@nokia.com; / WI rapporteur name: Petri Vasenkari, Nokia
- 913: 8/12/23: FCD:06/06/2024->12/12/2023; Compl:0%->100%; Stat Rep: ->RP-233181; Rapporteur: Nokia->Petri Vasenkari, Nokia; Rap eMail: ->petri.j.vasenkari@nokia.com; / WI rapporteur name: Petri Vasenkari, Nokia
- 914: 6/10/23: WID:RP-230764->RP-232680; 2/1/24: WID:RP-232680->RP-233991 / WI rapporteur name: CATT
- 915: ; 7/6/23: Compl:0%->50%; 6/9/23: Compl:50%->80%; WID: RP-230764->RP-231450; Stat Rep: ->RP-231833; Rapporteur: CATT->Shan Huiping, CATT; Rap eMail: ->shanhuiping@catt.cn; ; 8/12/23: Compl:80%->100%; Stat Rep: RP-231833->RP-233005; / WI rapporteur name: Shan Huiping, CATT
- 916: 6/9/23: WID: RP-230764->RP-231450; Stat Rep: ->RP-231833; Rapporteur: CATT->Shan Huiping, CATT; Rap eMail: ->shanhuiping@catt.cn¦01/24: stopped at 0% at RAN#102 / WI rapporteur name: Shan Huiping, CATT
- 917: 29/3/23: WID:RP-223514->RP-230062 / WI rapporteur name: Ligado Networks
- 918: 17/3/23: FCD:06/06/2023->03/03/2023; Compl:0%->100%; Stat Rep: ->RP-230061; Rapporteur: Ligado Networks->Ojas Choksi, Ligado Networks; Rap eMail: ->ojas.choksi@ligado.com; / WI rapporteur name: Ojas Choksi, Ligado Networks
- 919: 17/3/23: FCD:06/06/2023->03/03/2023; Compl:0%->100%; Stat Rep: ->RP-230061; Rapporteur: Ligado Networks->Ojas Choksi, Ligado Networks; Rap eMail: ->ojas.choksi@ligado.com; / WI rapporteur name: Ojas Choksi, Ligado Networks

| ID | WBS | Task | Duration | Start | Finish | Complete | Remaining | Total slack | Constraint | Resources | Work | Actual work | Acronym | PCG approved | Release | TSG approved | Status Report | Impacted TSs and TRs | TSG stopped |
| --- | --- | --- | --- | --- | --- | --- | --- | --- | --- | --- | --- | --- | --- | --- | --- | --- | --- | --- | --- |
| 920 | 444 | **Introduction of 900 MHz NR band in the US** | 262d | 2022-12-13 A | 2023-12-12 | 25% | 196.5d | 582d |  |  | 4192h |  | NR_900MHz_US | 50 | Rel-18 | 98 |  |  |  |
| 921 | 444.1 | Core Part: Introduction of 900 MHz NR band in the US | 262d | 2022-12-13 A | 2023-12-12 | 25% | 196.5d | 582d | finish no earlier than 2023-12-12 | R4 | 2096h |  | NR_900MHz_US-Core | 50 | Rel-18 | 98 | RP-231956 |  |  |
| 922 | 444.2 | Perf. part: Introduction of 900 MHz NR band in the US | 262d | 2022-12-13 A | 2023-12-12 | 25% | 196.5d | 582d | finish no earlier than 2023-12-12 | R4 | 2096h |  | NR_900MHz_US-Perf | 50 | Rel-18 | 98 | RP-231956 |  |  |
| 923 | 445 | **Rel-18 NR Inter-band Carrier Aggregation/Dual Connectivity for 2 bands DL with x bands UL (x=1,2)** | 520d | 2022-06-15 A | 2024-06-06 | 95% | 27.91d | 453d |  |  | 7752h | 3592h | NR_CADC_R18_2BDL_xBUL | 49 | Rel-18 | 96 |  |  |  |
| 924 | 445.1 | Core part: Rel-18 NR Inter-band Carrier Aggregation/Dual Connectivity for 2 bands DL with x bands UL (x=1,2) | 520d | 2022-06-15 A | 2024-06-06 | 90% | 52d | 453d | finish no earlier than 2024-06-06 | R4 | 4160h |  | NR_CADC_R18_2BDL_xBUL-Core | 49 | Rel-18 | 96 | RP-240247 | 38.718-02-01 |  |
| 925 | 445.2 | Stopped - Perf. part: Rel-18 NR Inter-band Carrier Aggregation/Dual Connectivity for 2 bands DL with x bands UL (x=1,2) | 449d | 2022-06-15 A | 2024-03-01 A | 100% |  |  | finish no earlier than 2024-03-01 | R4 | 3592h | 3592h | NR_CADC_R18_2BDL_xBUL-Perf | 49 | Rel-18 | 96 | RP-240247 |  |  |
| 926 | 446 | **Rel-18 NR Inter-band Carrier Aggregation/Dual Connectivity for 3 bands DL with x bands UL (x=1,2)** | 520d | 2022-06-15 A | 2024-06-06 | 90% | 52d | 453d |  |  | 8312h |  | NR_CADC_R18_3BDL_xBUL | 49 | Rel-18 | 96 |  |  |  |
| 927 | 446.1 | Core part: Rel-18 NR Inter-band Carrier Aggregation/Dual Connectivity for 3 bands DL with x bands UL (x=1,2) | 520d | 2022-06-15 A | 2024-06-06 | 90% | 52d | 453d | finish no earlier than 2024-06-06 | R4 | 4160h |  | NR_CADC_R18_3BDL_xBUL-Core | 49 | Rel-18 | 96 | RP-240167 | 38.718-03-01 |  |
| 928 | 446.2 | Perf. part: Rel-18 NR Inter-band Carrier Aggregation/Dual Connectivity for 3 bands DL with x bands UL (x=1,2) | 519d | 2022-06-16 A | 2024-06-06 | 90% | 51.9d | 453d | finish no earlier than 2024-06-06 | R4 | 4152h |  | NR_CADC_R18_3BDL_xBUL-Perf | 49 | Rel-18 | 96 | RP-240167 |  |  |
| 929 | 447 | **High Power UE support for NR bands n100 and n101 for Rail Mobile Radio (RMR) in Europe** | 390d | 2022-06-16 | 2023-12-12 |  |  | 582d |  |  | 3120h |  | NR_RAIL_HPUE_n100_n101 | 49 | Rel-18 | 96 |  |  |  |
| 930 | 447.1 | Core part: High Power UE support for NR bands n100 and n101 for Rail Mobile Radio (RMR) in Europe | 390d | 2022-06-16 | 2023-12-12 |  |  | 582d | finish no earlier than 2023-12-12 | R4 | 3120h |  | NR_RAIL_HPUE_n100_n101-Core | 49 | Rel-18 | 96 | RP-222544 |  |  |
| 931 | 448 | **Rel-18 NR intra band Carrier Aggregation for xCC DL/yCC UL including contiguous and non-contiguous spectrum (x>=y)** | 520d | 2022-06-15 A | 2024-06-06 | 91% | 46.8d | 453d |  |  | 7288h | 3128h | NR_CA_R18_Intra | 49 | Rel-18 | 96 |  |  |  |
| 932 | 448.1 | Core part: Rel-18 NR intra band Carrier Aggregation for xCC DL/yCC UL including contiguous and non-contiguous spectrum (x>=y) | 520d | 2022-06-15 A | 2024-06-06 | 91% | 46.8d | 453d | finish no earlier than 2024-06-06 | R4 | 4160h |  | NR_CA_R18_Intra-Core | 49 | Rel-18 | 96 | RP-240237 | 38.718-01-01 |  |
| 933 | 448.2 | Stopped - Perf. part: Rel-18 NR intra band Carrier Aggregation for xCC DL/yCC UL including contiguous and non-contiguous spectrum (x>=y) | 391d | 2022-06-15 A | 2023-12-12 | 91% | 35.19d | 0d | finish no earlier than 2024-03-01 | R4 | 3128h | 3128h | NR_CA_R18_Intra-Perf | 49 | Rel-18 | 96 | RP-240237 |  | 102 |
| 934 | 449 | **Rel-18 NR inter-band Carrier Aggregation/Dual Connectivity for y bands DL (y=4, 5, 6) with x bands UL (x=1, 2)** | 520d | 2022-06-15 A | 2024-06-06 | 60% | 208d | 453d |  |  | 8320h |  | NR_CADC_R18_yBDL_xBUL | 49 | Rel-18 | 96 |  |  |  |
| 935 | 449.1 | Core part: Rel-18 NR inter-band Carrier Aggregation/Dual Connectivity for y bands DL (y=4, 5, 6) with x bands UL (x=1, 2) | 520d | 2022-06-15 A | 2024-06-06 | 60% | 208d | 453d | finish no earlier than 2024-06-06 | R4 | 4160h |  | NR_CADC_R18_yBDL_xBUL-Core | 49 | Rel-18 | 96 | RP-240502 |  |  |
| 936 | 449.2 | Perf. part: Rel-18 NR inter-band Carrier Aggregation/Dual Connectivity for y bands DL (y=4, 5, 6) with x bands UL (x=1, 2) | 520d | 2022-06-15 A | 2024-06-06 | 60% | 208d | 453d | finish no earlier than 2024-06-06 | R4 | 4160h |  | NR_CADC_R18_yBDL_xBUL-Perf | 49 | Rel-18 | 96 | RP-240502 |  |  |
| 937 | 450 | **APT 600MHz NR band** | 188d | 2022-06-15 A | 2023-03-03 A | 100% |  |  |  |  | 3008h | 3008h | NR_600MHz_APT | 49 | Rel-18 | 96 |  |  |  |
| 938 | 450.1 | Core part: APT 600MHz NR band | 188d | 2022-06-15 A | 2023-03-03 A | 100% |  |  | finish no earlier than 2023-03-03 | R4 | 1504h | 1504h | NR_600MHz_APT-Core | 49 | Rel-18 | 96 | RP-230053 | 38.892 |  |
| 939 | 450.2 | Perf. part: APT 600MHz NR band | 188d | 2022-06-15 A | 2023-03-03 A | 100% |  |  | finish no earlier than 2023-03-03 | R4 | 1504h | 1504h | NR_600MHz_APT-Perf | 49 | Rel-18 | 96 | RP-230053 |  |  |
| 940 | 451 | **Stopped - Introduction of additional 6GHz NR licensed bands** | 390d | 2022-06-16 A | 2023-12-12 A | 100% |  |  |  |  | 6240h | 6240h | NR_6GHz_add_bands | 49 | Rel-18 | 96 |  |  | 102 |
| 941 | 451.1 | Stopped - Core part: Introduction of additional 6GHz NR licensed bands | 390d | 2022-06-16 A | 2023-12-12 A | 100% |  |  | finish no earlier than 2023-12-12 | R4 | 3120h | 3120h | NR_6GHz_add_bands-Core | 49 | Rel-18 | 96 | RP-233184 |  | 102 |
| 942 | 451.2 | Stopped - Perf. part: Introduction of additional 6GHz NR licensed bands | 390d | 2022-06-16 A | 2023-12-12 A | 100% |  |  | finish no earlier than 2023-12-12 | R4 | 3120h | 3120h | NR_6GHz_add_bands-Perf | 49 | Rel-18 | 96 | RP-233184 |  | 102 |
| 943 | 452 | **Additional NR bands for UL-MIMO in Rel-18** | 655d | 2022-06-15 A | 2024-12-12 | 84% | 102.76d | 318d |  |  | 10376h | 7184h | NR_bands_UL_MIMO_R18 | 49 | Rel-18 | 96 |  |  |  |
| 944 | 452.1 | Core part: Additional NR bands for UL-MIMO in Rel-18 | 449d | 2022-06-15 A | 2024-03-01 A | 100% |  |  | finish no earlier than 2024-03-01 | R4 | 3592h | 3592h | NR_bands_UL_MIMO_R18-Core | 49 | Rel-18 | 96 | RP-240421 |  |  |
| 945 | 452.2 | stopped - Perf. part: Additional NR bands for UL-MIMO in Rel-18 | 449d | 2022-06-15 A | 2024-03-01 A | 100% |  |  | finish no earlier than 2024-03-01 | R4 | 3592h | 3592h | NR_bands_UL_MIMO_R18-Perf | 49 | Rel-18 | 96 | RP-233198 |  | 102 |
| 946 | 452.3 | UE Conformance - Additional NR bands for UL-MIMO in Rel-18 | 399d | 2023-06-08 A | 2024-12-12 | 49% | 203.49d | 318d | finish no earlier than 2024-12-12 | R5 | 3192h |  | NR_bands_UL_MIMO_R18-UEConTest | 51 | Rel-18 | 100 | RP-240052 |  |  |

Notes:
- 920: 29/3/23: WID:RP-223529->RP-230723; 2/1/24: WID:RP-230723->RP-234044 / WI rapporteur name: Anterix
- 921: 17/3/23: Compl:0%->5%; Stat Rep: ->RP-230348; Rapporteur: Anterix->Emil Olbrich, Anterix; Rap eMail: ->eolbrich@anterix.com; ; 21/9/23: Compl:5%->25%; Stat Rep: RP-230348->RP-231956; Rapporteur: Emil Olbrich, Anterix->Gene Fong, Qualcomm Incorporated; Rap eMail: eolbrich@anterix.com->gfong@qti.qualcomm.com; / WI rapporteur name: Gene Fong, Qualcomm Incorporated / WI rapporteur e-mail: gfong@qti.qualcomm.com
- 922: 17/3/23: Stat Rep: ->RP-230348; Rapporteur: Anterix->Emil Olbrich, Anterix; Rap eMail: ->eolbrich@anterix.com; ; 21/9/23: Compl:0%->25%; Stat Rep: RP-230348->RP-231956; Rapporteur: Emil Olbrich, Anterix->Gene Fong, Qualcomm Incorporated; Rap eMail: eolbrich@anterix.com->gfong@qti.qualcomm.com; / WI rapporteur name: Gene Fong, Qualcomm Incorporated / WI rapporteur e-mail: gfong@qti.qualcomm.com
- 923: 23/9/22: WID:RP-221876->RP-222079; 9/1/23: WID:RP-222079->RP-222904; 29/3/23: WID:RP-222904->RP-230133; 6/10/23: WID:RP-230133->RP-231840; 2/1/24: WID:RP-231840->RP-232920; 2/4/24: WID:RP-232920->RP-240761 / WI rapporteur name: ZTE
- 924: 9/9/22: Comp...; 23/9/22: 38.718-02-01 added;; 9/12/22: FCD:23/12/2022->01/12/2023; Compl:5%->20%; Stat Rep: ->RP-222905; Rapporteur: ZTE->Wubin, Zhou, ZTE; Rap eMail: ->zhou.wubin@zte.com.cn; 17/3/23: FCD:30/11/2023->12/12/2023; Compl:2.....; 14/3/24: FCD:01/03/2024->06/06/2024; Compl:85%->90%; Stat Rep: RP-232922->RP-240247; / WI rapporteur name: Wubin, Zhou, ZTE / WI rapporteur e-mail: zhou.wubin@zte.com.cn
- 925: 9/9/22: Comp...; 9/12/22: FCD:23/12/2022->01/12/2023; Compl:5%->20%; Stat Rep: ->RP-222905; Rapporteur: ZTE->Wubin, Zhou, ZTE; Rap eMail: ->zhou.wubin@zte.com.cn; 17/3/23: FCD:30/11/2023->12/12/2023; Compl:20%->40%; Stat Rep: RP-222905->.....; 2/4/24: stopped at 85% / WI rapporteur name: Wubin, Zhou, ZTE / WI rapporteur e-mail: zhou.wubin@zte.com.cn
- 926: 23/9/22: WID:RP-221877->RP-222092; 9/1/23: WID:RP-222092->RP-222834; 29/3/23: WID:RP-222834->RP-230084; 6/10/23: WID:RP-230084->RP-231860; 2/1/24: WID:RP-231860->RP-233231; 2/4/24: WID:RP-233231->RP-240166 / WI rapporteur name: ZTE
- 927: 9/9/22: Comp...; 23/9/22: 38.718-03-01 added;; 9/12/22: FCD:23/12/2022->01/12/2023; Compl:10%->15%; Stat Rep: ->RP-222835; Rapporteur: ZTE->Zhifeng Ma, ZTE; Rap eMail: ->ma.zhifeng@zte.com.cn; 17/3/23: FCD:30/11/2023->12/12/2023; Compl:1.....; 14/3/24: FCD:01/03/2024->06/06/2024; Compl:85%->90%; Stat Rep: RP-233232->RP-240167; / WI rapporteur name: Zhifeng Ma, ZTE / WI rapporteur e-mail: ma.zhifeng@zte.com.cn
- 928: 9/9/22: CD:1...; 9/12/22: FCD:23/12/2022->01/12/2023; Stat Rep: ->RP-222835; Rapporteur: ZTE->Zhifeng Ma, ZTE; Rap eMail: ->ma.zhifeng@zte.com.cn; 17/3/23: Compl:0%->40%; Stat Rep: RP-222835->RP-230085; ...; 6/9/23: Compl:60%->75%; WID: RP...; 14/3/24: FCD:01/03/2024->06/06/2024; Compl:85%->90%; Stat Rep: RP-233232->RP-240167; / WI rapporteur name: Zhifeng Ma, ZTE / WI rapporteur e-mail: ma.zhifeng@zte.com.cn
- 929: WI rapporteur name: Union Internationale Chemins de Fer (UIC)
- 930: WI rapporteur name: Union Internationale Chemins de Fer (UIC)
- 931: 23/9/22: WID:RP-221835->RP-222105; 9/1/23: WID:RP-222105->RP-222846; 29/3/23: WID:RP-222846->RP-230067; 6/10/23: WID:RP-230067->RP-231623; 2/1/24: WID:RP-231623->RP-233990; 2/4/24: WID:RP-233990->RP-240238 / WI rapporteur name: Ericsson
- 932: 9/9/22: CD:1...; 23/9/22: 38.718-01-01 added;; 9/12/22: FCD:23/12/2022->01/12/2023; Compl:0%->71%; Stat Rep: ->RP-222845; Rapporteur: Ericsson->Per Lindell, Ericsson; Rap eMail: ->per.lindell@ericsson.com; 17/3/23: FCD:30/11/2023->12/12/.....; 14/3/24: FCD:01/03/2024->06/06/2024; Compl:92%->91%; Stat Rep: RP-233221->RP-240237; / WI rapporteur name: Per Lindell, Ericsson / WI rapporteur e-mail: per.lindell@ericsson.com
- 933: 9/9/22: CD:1...; 9/12/22: FCD:23/12/2022->01/12/2023; Compl:0%->71%; Stat Rep: ->RP-222845; Rapporteur: Ericsson->Per Lindell, Ericsson; Rap eMail: ->per.lindell@ericsson.com; 17/3/23: FCD:30/11/2023->12/12/2023; Compl:71%->57%; Stat Rep.....; 14/3/24: FCD:01/03/2024->12/12/2023; Compl:100%->91%; Stat Rep: RP-233221->RP-240237; / WI rapporteur name: Per Lindell, Ericsson / WI rapporteur e-mail: per.lindell@ericsson.com
- 934: 23/9/22: WID:RP-221838->RP-222318; 9/1/23: WID:RP-222318->RP-223438; 29/3/23: WID:RP-223438->RP-230421; 6/10/23: WID:RP-230421->RP-231738; 2/1/24: WID:RP-231738->RP-233696; 2/4/24: WID:RP-233696->RP-240501 / WI rapporteur name: Ericsson
- 935: 9/9/22: Comp...; 9/12/22: FCD:23/12/2022->01/12/2023; Compl:25%->29%; Stat Rep: ->RP-222911; Rapporteur: Ericsson->Reihaneh Malekafzaliardakani, Ericsson; Rap eMail: ->reihaneh.malekafzaliardakani@ericsson.com; 17/3/23: FCD:30/11/2023->1.....; 14/3/24: FCD:01/03/2024->06/06/2024; Compl:67%->60%; Stat Rep: RP-233694->RP-240502; / WI rapporteur name: Reihaneh Malekafzaliardakani, Ericsson / WI rapporteur e-mail: reihaneh.malekafzaliardakani@ericsson.com
- 936: 9/9/22: Comp...; 9/12/22: FCD:23/12/2022->01/12/2023; Compl:25%->29%; Stat Rep: ->RP-222911; Rapporteur: Ericsson->Reihaneh Malekafzaliardakani, Ericsson; Rap eMail: ->reihaneh.malekafzaliardakani@ericsson.com; 17/3/23: FCD:30/11/2023->1.....; 14/3/24: FCD:01/03/2024->06/06/2024; Compl:67%->60%; Stat Rep: RP-233694->RP-240502; / WI rapporteur name: Reihaneh Malekafzaliardakani, Ericsson / WI rapporteur e-mail: reihaneh.malekafzaliardakani@ericsson.com
- 937: 9/1/23: WID:RP-221778->RP-223265; 29/3/23: WID:RP-223265->RP-230060 / WI rapporteur name: Spark NZ Ltd
- 938: 9/9/22: Comp...; 23/9/22: 38.892 added;; 9/12/22: FCD:22/12/2022->01/03/2023; Compl:10%->95%; Stat Rep: ->RP-222803; Rapporteur: Spark NZ Ltd->Mansoor Shafi, Spark New Zealand; Rap eMail: ->Mansoor.shafi@spark.co.nz; 17/3/23: Compl:95%->... / WI rapporteur name: Mansoor Shafi, Spark New Zealand / WI rapporteur e-mail: Mansoor.shafi@spark.co.nz
- 939: 9/9/22: Comp...; 9/12/22: FCD:23/03/2023->01/03/2023; Compl:10%->60%; Stat Rep: ->RP-222803; Rapporteur: Spark NZ Ltd->Mansoor Shafi, Spark New Zealand; Rap eMail: ->Mansoor.shafi@spark.co.nz; 17/3/23: Compl:60%->100%; WID: RP-223265->RP... / WI rapporteur name: Mansoor Shafi, Spark New Zealand / WI rapporteur e-mail: Mansoor.shafi@spark.co.nz
- 940: 23/9/22: WID:RP-221845->RP-22249801/24: stopped at 0% at RAN#102 / WI rapporteur name: Huawei
- 941: 9/9/22: CD:1…; 9/12/22: FCD:23/12/2022->01/12/2023; WID: RP-221845->RP-222498; Stat Rep: ->RP-223341; Rapporteur: Huawei->Liehai Liu, Dominique Everaere, Iwajlo Angelow, Fei Xue, Huawei, Ericsson, Nokia, ZTE Corporation¦01/24: stopped at 0% at RAN#102 / WI rapporteur name: Liehai Liu, Dominique Everaere, Iwajlo Angelow, Fei Xue, Huawei, Ericsson, Nokia, ZTE Corporation / WI rapporteur e-mail: liuliehai@huawei.com, dominique.everaere@ericsson.com, iwajlo.angelow@nokia.com, xue.fei25@zte.com.cn
- 942: 9/9/22: CD:1...; 9/12/22: FCD:23/12/2022->01/12/2023; WID: RP-221845->RP-222498; Stat Rep: ->RP-223341; Rapporteur: Huawei->Liehai Liu, Dominique Everaere, Iwajlo Angelow, Fei Xue, Huawei, Ericsson, Nokia, ZTE Corporation; Rap eMail: ->liu...; 8/12/23: Stat Rep: RP-232364->RP-233184¦01/24: stopped at 0% / WI rapporteur name: Liehai Liu, Dominique Everaere, Iwajlo Angelow, Fei Xue, Huawei, Ericsson, Nokia, ZTE Corporation / WI rapporteur e-mail: liuliehai@huawei.com, dominique.everaere@ericsson.com, iwajlo.angelow@nokia.com, xue.fei25@zte.com.cn
- 943: 23/9/22: WID:RP-221844->RP-222509; 9/1/23: WID:RP-222509->RP-223516; 6/10/23: WID:RP-223516->RP-232374; 2/1/24: WID:RP-232374->RP-234040; 2/4/24: WID:RP-234040->RP-240422 / WI rapporteur name: Huawei
- 944: 9/9/22: Comp...; 9/12/22: FCD:23/12/2022->01/12/2023; Compl:10%->15%; Stat Rep: ->RP-223351; Rapporteur: Huawei->Xiang Gao, Huawei; Rap eMail: ->gaoxiang74@huawei.com; 17/3/23: FCD:30/11/2023->12/12/2023; Compl:15%->25%; Stat Rep: RP-223.....; 14/3/24: Compl:90%->100%; Stat Rep: RP-233198->RP-240421; / WI rapporteur name: Xiang Gao, Huawei / WI rapporteur e-mail: gaoxiang74@huawei.com
- 945: 9/9/22: CD:1...; 9/12/22: FCD:23/12/2022->01/12/2023; Compl:0%->15%; Stat Rep: ->RP-223351; Rapporteur: Huawei->Xiang Gao, Huawei; Rap eMail: ->gaoxiang74@huawei.com; 17/3/23: FCD:30/11/2023->12/12/2023; Compl:15%->25%; Stat Rep: RP-2233.....; 8/12/23: FCD:12/12/2023->01/03/2024; Compl:70%->90%; Stat Rep: RP-232373->RP-233198¦01/24: stopped at 90% at RAN#102 / WI rapporteur name: Xiang Gao, Huawei / WI rapporteur e-mail: gaoxiang74@huawei.com
- 946: 6/9/23: Compl:0%->49%; Stat Rep: ->RP-231550; Rapporteur: China Unicom->Shi，Yu, China Unicom; Rap eMail: ->shiyu19@chinaunicom.cn; ; 8/12/23: Stat Rep: RP-231550->RP-232771; ; 2/1/24: WID:RP-230868->RP-232772; 14/3/24: FCD:05/06/2024->12/12/2024; Stat Rep: RP-232771->RP-240052; / WI rapporteur name: Shi，Yu, China Unicom / WI rapporteur e-mail: shiyu19@chinaunicom.cn

| ID | WBS | Task | Type | Duration | Start | Finish | Complete | Remaining | Total slack | Constraint | Resources | Work | Actual work | Acronym | PCG approved | WI rapporteur name | Release | TSG approved | WI rapporteur e-mail | Status Report | Impacted TSs and TRs | TSG stopped |
| --- | --- | --- | --- | --- | --- | --- | --- | --- | --- | --- | --- | --- | --- | --- | --- | --- | --- | --- | --- | --- | --- | --- |
| 947 | 453 | **Enhancements of NR shared spectrum bands** |  | 255d | 2022-06-15 A | 2023-06-06 | 99% | 1.27d | 718d |  |  | 4080h | 3544h | NR_unlic_enh | 49 | Apple | Rel-18 | 96 |  |  |  |  |
| 948 | 453.1 | Core part: Enhancements of NR shared spectrum bands |  | 255d | 2022-06-15 A | 2023-06-06 A | 100% |  |  | finish no earlier than 2023-06-06 | R4 | 2040h | 2040h | NR_unlic_enh-Core | 49 | Daniel Popp, Apple Inc. | Rel-18 | 96 | d_popp@apple.com | RP-230729 |  |  |
| 949 | 453.2 | Perf. part: Enhancements of NR shared spectrum bands |  | 255d | 2022-06-15 A | 2023-06-06 | 99% | 2.55d | 718d | finish no earlier than 2023-06-06 | R4 | 2040h | 1504h | NR_unlic_enh-Perf | 49 | Daniel Popp, Apple Inc. | Rel-18 | 96 | d_popp@apple.com | RP-230729 |  |  |
| 950 | 454 | **Introduction of LTE TDD band in 1670-1675 MHz** |  | 457d | 2022-03-15 A | 2023-12-12 A | 100% |  |  |  |  | 4640h | 4640h | LTE_TDD_1670_1675MHz | 48 | Ligado Networks | Rel-18 | 95 |  |  |  |  |
| 951 | 454.1 | Core part: Introduction of LTE TDD band in 1670-1675 MHz |  | 188d | 2022-03-15 A | 2022-12-01 A | 100% |  |  | finish no earlier than 2022-12-01 | R4 | 1504h | 1504h | LTE_TDD_1670_1675MHz-Core | 48 | Ojas Choksi, Ligado Networks | Rel-18 | 95 | ojas.choksi@ligado.com | RP-222830 |  |  |
| 952 | 454.2 | Perf. part: Introduction of LTE TDD band in 1670-1675 MHz |  | 188d | 2022-03-15 A | 2022-12-01 A | 100% |  |  | finish no earlier than 2022-12-01 | R4 | 1504h | 1504h | LTE_TDD_1670_1675MHz-Perf | 48 | Ojas Choksi, Ligado Networks | Rel-18 | 95 | ojas.choksi@ligado.com | RP-222830 |  |  |
| 953 | 454.3 | UE Conformance - Introduction of LTE TDD band in 1670 – 1675 MHz |  | 204d | 2023-03-03 A | 2023-12-12 A | 100% |  |  | finish no earlier than 2023-12-12 | R5 | 1632h | 1632h | LTE_TDD_1670_1675MHz-UEConTest | 50 | Ojas Choksi, Ligado Networks | Rel-18 | 99 | ojas.choksi@ligado.com | RP-232784 |  |  |
| 954 | 455 | Study on UE support of regionally-defined subsets of an NR band |  | 188d | 2022-06-15 A | 2023-03-03 A | 100% |  |  | finish no earlier than 2023-03-03 | RP | 1504h | 1504h | FS_NR_subset_band_support | 49 | Gene Fong, Qualcomm Incorporated | Rel-18 | 96 | gfong@qti.qualcomm.com | RP-230340 | 38.893 |  |
| 955 | 456 | UE Conformance - New Rel-18 NR licensed bands and extension of existing NR bands |  | 525d | 2023-06-08 A | 2025-06-06 | 5% | 498.75d | 192d | finish no earlier than 2025-06-06 | R5 | 4200h |  | NR_lic_bands_BW_R18-UEConTest | 51 | Yuxin Hao, Huawei Technologies. Co., Ltd. | Rel-18 | 100 | haoyuxin@huawei.com | RP-240286 |  |  |
| 956 | 457 | Rel-18 Other NR and LTE | milestone | 0d? | 2019-03-07 | 2019-03-07 |  |  | 1828d |  |  |  |  |  |  |  | Rel-18 |  |  |  |  |  |
| 957 | 458 | **Rel-18 basket WI 3Tx NR inter-band UL Carrier Aggregation (CA) and EN-DC** |  | 197d | 2023-09-09 A | 2024-06-06 | 70% | 59.09d | 453d |  | R4 | 3152h | 1103.28h | R18_3Tx_NR_CA_ENDC | 51 | Oppo | Rel-18 | 101 |  |  |  |  |
| 958 | 458.1 | Core pat: Rel-18 basket WI 3Tx NR inter-band UL Carrier Aggregation (CA) and EN-DC |  | 197d | 2023-09-09 A | 2024-06-06 | 70% | 59.1d | 453d | finish no earlier than 2024-06-06 | R4 | 1576h |  | R18_3Tx_NR_CA_ENDC-Core | 51 | Jinqiang Xing, OPPO | Rel-18 | 101 | xingjinqiang@oppo.com | RP-240308 | 38.88 |  |
| 959 | 459 | **Rel-18 High power UE (power class m with 1<m<3) for a single FR1 band in UL of Dual Connectivity (DC) combinations of x bands (x=1,2,3, 4 for y=1 or x=1, 2 for y=2) LTE inter-band CA (xDL/1UL) and y bands NR inter-band CA (yDL/1UL)** |  | 457d | 2022-09-12 A | 2024-06-06 | 77% | 106.61d | 453d |  |  | 6280h | 2624h | HPUE_FR1_DC_LTE_NR_R18 | 49 | Ericsson | Rel-18 | 97 |  |  |  |  |
| 960 | 459.1 | Core part: Rel-18 High power UE (power class m with 1<m<3) for a single FR1 band in UL of Dual Connectivity (DC) combinations of x bands (x=1,2,3, 4 for y=1 or x=1, 2 for y=2) LTE inter-band CA (xDL/1UL) and y bands NR inter-band CA (yDL/1UL) |  | 457d | 2022-09-12 A | 2024-06-06 | 75% | 114.25d | 453d | finish no earlier than 2024-06-06 | R4 | 3656h |  | HPUE_FR1_DC_LTE_NR_R18-Core | 49 | Per Lindell, Ericsson | Rel-18 | 97 | per.lindell@ericsson.com | RP-240240 | 38.898 |  |
| 961 | 459.2 | Stopped - Perf. part: Rel-18 High power UE (power class m with 1<m<3) for a single FR1 band in UL of Dual Connectivity (DC) combinations of x bands (x=1,2,3, 4 for y=1 or x=1, 2 for y=2) LTE inter-band CA (xDL/1UL) and y bands NR inter-band CA (yDL/1UL) |  | 328d | 2022-09-12 A | 2023-12-12 | 79% | 68.88d | 0d | finish no earlier than 2024-03-01 | R4 | 2624h | 2624h | HPUE_FR1_DC_LTE_NR_R18-Perf | 49 | Per Lindell, Ericsson | Rel-18 | 97 | per.lindell@ericsson.com | RP-240240 |  | 102 |
| 962 | 460 | UE Conformance - Rel-18 High Power UE for NR CA and DC; and NR and LTE DC Configurations; |  | 525d | 2023-06-08 A | 2025-06-06 | 40% | 315d | 192d | finish no earlier than 2025-06-06 | R5 | 4200h |  | HPUE_NR_CADC_NR_LTE_DC_R18-UEConTest | 51 | Lei GAO, China Telecom | Rel-18 | 100 | gaol8@chinatelecom.cn | RP-240359 |  |  |
| 963 | 461 | **High-power UE operation for fixed-wireless/vehicle-mounted use cases in LTE bands and NR bands** |  | 520d | 2022-06-15 A | 2024-06-06 | 59% | 212.57d | 453d |  |  | 6272h |  | LTE_NR_HPUE_FWVM_R18 | 49 | Nokia | Rel-18 | 96 |  |  |  |  |
| 964 | 461.1 | Core part: High-power UE operation for fixed-wireless/vehicle-mounted use cases in LTE bands and NR bands |  | 520d | 2022-06-15 A | 2024-06-06 | 80% | 104d | 453d | finish no earlier than 2024-06-06 | R4 | 4160h |  | LTE_NR_HPUE_FWVM_R18-Core | 49 | Petri Vasenkari, Nokia | Rel-18 | 96 | petri.j.vasenkari@nokia.com | RP-240362 | 37.829 |  |
| 965 | 461.2 | UE Conformance - High-power UE operation for fixed-wireless/vehicle-mounted use cases in LTE bands and NR bands in Rel-18 |  | 264d | 2023-06-08 A | 2024-06-06 | 18% | 216.48d | 453d | finish no earlier than 2024-06-06 | R5 | 2112h |  | LTE_NR_HPUE_FWVM_R18-UEConTest | 51 | Tuomo S yn j kangas, Nokia | Rel-18 | 100 | tuomo.saynajakangas@nokia.com | RP-240094 |  |  |
| 966 | 462 | UE Conformance - Rel-18 NR CA and DC; and NR and LTE DC Configurations |  | 525d | 2023-06-08 A | 2025-06-06 | 5% | 498.75d | 192d | finish no earlier than 2025-06-06 | R5 | 4200h |  | NR_CADC_NR_LTE_DC_R18-UEConTest | 51 | Chunying GU, Huawei Technologies. Co., Ltd. | Rel-18 | 100 | guchunying@huawei.com | RP-240284 |  |  |
| 967 | 463 | **4Rx handheld UE for low NR bands (<1GHz) and/or 3Tx for NR inter-band UL Carrier Aggregation (CA) and EN-DC** |  | 652d | 2022-12-13 A | 2025-06-06 | 44% | 362.7d | 192d |  |  | 5216h | 2096h | 4Rx_low_NR_band_handheld_3Tx_NR_CA_ENDC | 50 | Oppo | Rel-18 | 98 |  |  |  |  |
| 968 | 463.1 | Core part: 4Rx handheld UE for low NR bands (<1GHz) and/or 3Tx for NR inter-band UL Carrier Aggregation (CA) and EN-DC |  | 262d | 2022-12-13 A | 2023-12-12 A | 100% |  |  | finish no earlier than 2023-12-12 | R4 | 2096h | 2096h | 4Rx_low_NR_band_handheld_3Tx_NR_CA_ENDC-Core | 50 | Jinqiang Xing, OPPO | Rel-18 | 98 | xingjinqiang@oppo.com | RP-232937 |  |  |
| 969 | 463.2 | UE Conformance - 4Rx handheld UE for low NR bands (<1GHz) and/or 3Tx for NR inter-band UL Carrier Aggregation (CA) and EN-DC |  | 390d | 2023-12-13 A | 2025-06-06 | 7% | 362.7d | 192d | finish no earlier than 2025-06-06 | R5 | 3120h |  | 4Rx_low_NR_band_handheld_3Tx_NR_CA_ENDC-UEConTest | 52 | Yaping ZHANG, Huawei | Rel-18 | 102 | zhangyaping13@huawei.com | RP-240289 |  |  |
| 970 | 464 | **Simultaneous Rx/Tx band combinations for NR CA/DC, NR SUL and LTE/NR DC in Rel-18** |  | 720d | 2022-09-08 A | 2025-06-06 | 68% | 230.78d | 192d |  |  | 9432h | 3104h | LTE_NR_Simult_RxTx_R18 | 49 | Huawei | Rel-18 | 97 |  |  |  |  |
| 971 | 464.1 | Core part: Simultaneous Rx/Tx band combinations for NR CA/DC, NR SUL and LTE/NR DC in Rel-18 |  | 459d | 2022-09-08 A | 2024-06-06 | 90% | 45.9d | 453d | finish no earlier than 2024-06-06 | R4 | 3672h |  | LTE_NR_Simult_RxTx_R18-Core | 49 | Dan Hu, Huawei | Rel-18 | 97 | hudan11@huawei.com | RP-240423 | 38.894 |  |
| 972 | 464.2 | Stopped - Perf. part: Simultaneous Rx/Tx band combinations for NR CA/DC, NR SUL and LTE/NR DC in Rel-18 |  | 388d | 2022-09-08 A | 2024-03-01 A | 100% |  |  | finish no earlier than 2024-03-01 | R4 | 3104h | 3104h | LTE_NR_Simult_RxTx_R18-Perf | 49 | Dan Hu, Huawei | Rel-18 | 97 | hudan11@huawei.com | RP-233201 |  | 102 |
| 973 | 464.3 | UE Conformance - Simultaneous Rx/Tx band combinations for NR CA/DC, NR SUL and LTE/NR DC in Rel-18 |  | 332d | 2024-03-03 | 2025-06-06 |  |  | 192d | finish no earlier than 2025-06-06 | R5 | 2656h |  | LTE_NR_Simult_RxTx_R18-UEConTest |  | Huawei | Rel-18 |  |  |  |  |  |

Notes:
- 947: 23/9/22: WID:RP-221813->RP-222174; 29/3/23: WID:RP-222174->RP-230730
- 948: 9/9/22: Comp...; 9/12/22: FCD:23/03/2023->01/03/2023; Compl:15%->50%; Stat Rep: ->RP-223194; Rapporteur: Apple->Daniel Popp, Apple Inc.; Rap eMail: ->d_popp@apple.com; 17/3/23: FCD:03/03/2023->08/09/2023; Compl:50%->85%; Stat Rep: RP-223...
- 949: 9/12/22: FCD:15/03/2023->01/03/2023; Compl:0%->50%; Stat Rep: RP-222175->RP-223194; Rapporteur: Apple->Daniel Popp, Apple Inc.; Rap eMail: ->d_popp@apple.com; 17/3/23: Compl:50%->100%; Stat Rep: RP-223194->RP-230152; 31/3/23: FCD:03/03/2023->06/06...
- 950: 9/1/23: WID:RP-220971->RP-222831
- 951: ; 6/6/22: Compl:0%->15% ; 6/6 ; 20/6/22: Rapporteur: Ligado Networks->Ojas Choksi, Ligado Networks; Rap eMail: ->ojas.choksi@ligado.com ...; 9/12/22: FCD:22/12/2022->01/12/2022; Compl:50%->100%; Stat Rep: RP-221061->RP-222830; 9/1/23: 100%->100
- 952: ; 6/6/22: CD:15/12/2022->22/12/2022; 6/6/22: Stat Rep: ->RP-221061; 20/6/22: Rapporteur: Ligado Networks->Ojas Choksi, Ligado Networks; Rap eMail: ->ojas.choksi@ligado.com; 9/12/22: FCD:22/12/2022->01/12/2022; Compl:0%->100%; Stat Rep: RP-221061->RP...
- 953: ; 7/6/23: Compl:0%->83%; 7/6/23: CD:09/09/2023->...; 6/9/23: Compl:83%->99%; WID: RP-230063->RP-230907; Stat Rep: ->RP-231546; Rapporteur: Ligado Networks->Ojas Choksi, Ligado Networks; Rap eMail: ->ojas.choksi@ligado.com; ; 6/10/23: WID:RP-230907->RP...; 2/1/24: WID:RP-231545->RP-232783
- 954: 23/9/22: FCD:15/12/2022->12/20; 23/9/22: 0%->40; 23/9/22: WID:RP-221872->RP-222220; 23/9/22: 38.893 added;; 9/1/23: WID:RP-222220->RP-223556; 29/3/23: FCD:12/12/2023->03/23; 29/3/23: 40%->100; 31/3/23: Stat Rep: RP-222222->RP-230340; Rapporteur: Qualcomm->Gene Fong, Qualcomm Incorporated; Rap eMail: ->gfong@qti.qualcomm.com;
- 955: 6/9/23: FCD:06/06/2025->06/06/2024; Compl:0%->5%; Stat Rep: ->RP-232360; Rapporteur: Huawei->Yuxin Hao, Huawei Technologies. Co., Ltd.; Rap eMail: ->haoyuxin@huawei.com; ; 6/10/23: WID:RP-231249->RP-232361; 8/12/23: FCD:06/06/2024->06/06/2025; Stat Rep...; 2/4/24: WID:RP-232361->RP-240287
- 956: -
- 957: 2/1/24: WID:RP-232674->RP-232941; 2/4/24: WID:RP-232941->RP-240307
- 958: 8/12/23: FCD:12/12/2023->01/03/2024; Compl:0%->30%; Stat Rep: ->RP-232940; Rapporteur: Oppo->Jinqiang Xing, OPPO; Rap eMail: ->xingjinqiang@oppo.com; ; 4/1/24: 38.880 added;; 14/3/24: FCD:01/03/2024->06/06/2024; Compl:30%->70%; Stat Rep: RP-232940->RP-240308; List of Impacted TS & TR updated;
- 959: 9/1/23: WID:RP-222660->RP-222848; 29/3/23: WID:RP-222848->RP-230069; 6/10/23: WID:RP-230069->RP-231625; 2/1/24: WID:RP-231625->RP-233977; 2/4/24: WID:RP-233977->RP-240241
- 960: 9/12/22: FCD:12/12/2023->01/12/2023; Compl:0%->14%; Stat Rep: ->RP-222847; Rapporteur: Ericsson->Per Lindell, Ericsson; Rap eMail: ->per.lindell@ericsson.com; 17/3/23: FCD:30/11/2023->12/12/2023; Compl:14%->19%; Stat Rep: RP-222847->RP-230068; 17/...;...; 14/3/24: FCD:01/03/2024->06/06/2024; Compl:77%->75%; Stat Rep: RP-233224->RP-240240;
- 961: 9/12/22: FCD:12/12/2023->01/12/2023; Compl:0%->14%; Stat Rep: ->RP-222847; Rapporteur: Ericsson->Per Lindell, Ericsson; Rap eMail: ->per.lindell@ericsson.com; 17/3/23: FCD:30/11/2023->12/12/2023; Compl:14%->19%; Stat Rep: RP-222847->RP-230068; ;...; 6...; 14/3/24: FCD:01/03/2024->12/12/2023; Compl:100%->79%; Stat Rep: RP-233224->RP-240240;
- 962: 6/9/23: FCD:06/06/2025->06/06/2024; Compl:0%->5%; Stat Rep: ->RP-232259; Rapporteur: China Telecom->Lei GAO, China Telecom; Rap eMail: ->gaol8@chinatelecom.cn; ; 8/12/23: FCD:06/06/2024->06/06/2025; Compl:5%->15%; Stat Rep: RP-232259->RP-233565; ; 14/3/24: FCD:05/06/2025->06/06/2025; Compl:15%->40%; Stat Rep: RP-233565->RP-240359;
- 963: 19/10/22: acronym corrected; 9/1/23: WID:RP-221841->RP-223424; 6/10/23: WID:RP-223424->RP-231615; 2/1/24: WID:RP-231615->RP-233180; 2/4/24: WID:RP-233180->RP-240361
- 964: 9/9/22: Comp...; 23/9/22: 37.829 added;; 9/12/22: FCD:23/12/2022->01/12/2023; Compl:10%->30%; WID: RP-222058->RP-221841; Stat Rep: ->RP-222825; Rapporteur: Nokia->Petri Vasenkari, Nokia; Rap eMail: ->petri.j.vasenkari@nokia.com; 17/3/23:.....; 14/3/24: FCD:01/03/2024->06/06/2024; Compl:70%->80%; Stat Rep: RP-233178->RP-240362;
- 965: 6/9/23: Compl:0%->18%; Stat Rep: ->RP-231612; Rapporteur: Nokia->Tuomo S yn j kangas, Nokia; Rap eMail: ->tuomo.saynajakangas@nokia.com; ; 6/10/23: WID:RP-231429->RP-231613; 8/12/23: WID: RP-231615->RP-231613; Stat Rep: RP-231612->RP-232856; ; 14/3/24:...; 2/4/24: WID:RP-231613->RP-240095
- 966: 6/9/23: FCD:06/06/2025->06/06/2024; Compl:0%->5%; Stat Rep: ->RP-232359; Rapporteur: Huawei->Yuxin Hao, Huawei Technologies. Co., Ltd.; Rap eMail: ->haoyuxin@huawei.com; ; 8/12/23: FCD:06/06/2024->06/06/2025; Stat Rep: RP-232359->RP-233767; ; 14/3/24: ...; 2/4/24: WID:RP-231248->RP-240285
- 967: 29/3/23: WID:RP-223517->RP-230161; 6/10/23: WID:RP-230161->RP-231719; 2/1/24: WID:RP-231719->RP-234046
- 968: 17/3/23: Compl:0%->10%; Stat Rep: ->RP-230160; Rapporteur: Oppo->Jinqiang Xing, OPPO; Rap eMail: ->xingjinqiang@oppo.com; ; 29/6/23: 10%->70; 6/9/23: Compl:70%->85%; WID: RP-230161->RP-231013; Stat Rep: RP-231012->RP-231718; ; 8/12/23: Compl:85%->100%; Stat Rep: RP-231718->RP-232937;
- 969: 14/3/24: Compl:0%->7%; Stat Rep: ->RP-240289; Rapporteur: Huawei->Yaping ZHANG, Huawei; Rap eMail: ->zhangyaping13@huawei.com; 2/4/24: corrected: rel-19->Rel-18
- 970: 9/1/23: WID:RP-222648->RP-223354; 2/1/24: WID:RP-223354->RP-234002; 2/4/24: WID:RP-234002->RP-240425
- 971: 9/12/22: Acronym:LTE_NR_Simult_RxTx_R18-Core->LTE_NR _Simult_RxTx_R18-Core; FCD:10/12/2023->01/12/2023; Compl:0%->20%; Stat Rep: ->RP-223353; Rapporteur: Huawei->Dan Hu, Huawei; Rap eMail: ->hudan11@huawei.com; 17/3/23: FCD:30/11/2023->12/12/2023; C.....; 14/3/24: FCD:01/03/2024->06/06/2024; Compl:85%->90%; Stat Rep: RP-233201->RP-240423;
- 972: 9/12/22: Acronym:LTE_NR_Simult_RxTx_R18-Perf->LTE_NR _Simult_RxTx_R18-Perf; FCD:10/12/2023->01/12/2023; Compl:0%->20%; Stat Rep: ->RP-223353; Rapporteur: Huawei->Dan Hu, Huawei; Rap eMail: ->hudan11@huawei.com; 17/3/23: FCD:30/11/2023->12/12/2023; C.....; 2/1/24: Stopped at 85% at RAN#102

| ID | WBS | Task | Duration | Start | Finish | Complete | Remaining | Total slack | Constraint | Resources | Work | Actual work | Acronym | PCG approved | WI rapporteur name | Release | TSG approved | Impacted TSs and TRs | WI rapporteur e-mail | Status Report | TSG stopped |
| --- | --- | --- | --- | --- | --- | --- | --- | --- | --- | --- | --- | --- | --- | --- | --- | --- | --- | --- | --- | --- | --- |
| 974 | 465 | **Enhancement of UE TRP (Total Radiated Power) and TRS (Total Radiated Sensitivity) requirements and test methodologies for FR1 (NR SA and EN-DC)** | 459d | 2022-09-08 A | 2024-06-06 | 85% | 66.63d | 453d |  |  | 6296h | 2640h | NR_FR1_TRP_TRS_enh | 49 | Vivo | Rel-18 | 97 |  |  |  |  |
| 975 | 465.1 | Core part: Enhancement of UE TRP and TRS requirements and test methodologies for FR1 (NR SA and EN-DC) | 330d | 2022-09-08 A | 2023-12-12 A | 100% |  |  | finish no earlier than 2023-12-12 | R4 | 2640h | 2640h | NR_FR1_TRP_TRS_enh-Core | 49 | Wang, Ruixin, vivo | Rel-18 | 97 | 38.87 | ruixin.wang@vivo.com | RP-240137 |  |
| 976 | 465.2 | Perf. Part: Enhancement of UE TRP and TRS requirements and test methodologies for FR1 (NR SA and EN-DC) | 457d | 2022-09-12 A | 2024-06-06 | 75% | 114.25d | 453d | finish no earlier than 2024-06-06 | R4 | 3656h |  | NR_FR1_TRP_TRS_enh-Perf | 49 | Wang, Ruixin, vivo | Rel-18 | 97 |  | ruixin.wang@vivo.com | RP-240137 |  |
| 977 | 466 | **Rel-18 single SUL band combinations for SA NR supplementary uplink (SUL), NSA NR SUL, NSA NR SUL with UL sharing from the UE perspective (ULSUP)** | 520d | 2022-06-15 A | 2024-06-06 | 95% | 27.91d | 453d |  |  | 7752h | 3592h | NR_SUL_combos_R18 | 49 | Huawei | Rel-18 | 96 |  |  |  |  |
| 978 | 466.1 | Core part: Rel-18 single SUL band combinations for SA NR supplementary uplink (SUL), NSA NR SUL, NSA NR SUL with UL sharing from the UE perspective (ULSUP) | 520d | 2022-06-15 A | 2024-06-06 | 90% | 52d | 453d | finish no earlier than 2024-06-06 | R4 | 4160h |  | NR_SUL_combos_R18-Core | 49 | Zhang, Peng, Huawei | Rel-18 | 96 | 37.718-00-00 | zhangpeng169@huawei.com | RP-240418 |  |
| 979 | 466.2 | Stopped - Perf. Part: Rel-18 single SUL band combinations for SA NR supplementary uplink (SUL), NSA NR SUL, NSA NR SUL with UL sharing from the UE perspective (ULSUP) | 449d | 2022-06-15 A | 2024-03-01 A | 100% |  |  | finish no earlier than 2024-03-01 | R4 | 3592h | 3592h | NR_SUL_combos_R18-Perf | 49 | Zhang, Peng, Huawei | Rel-18 | 96 |  | zhangpeng169@huawei.com | RP-240418 |  |
| 980 | 467 | **Rel-18 Dual Connectivity (DC) of 1 band LTE (1DL/1UL) and 1 NR band (1DL/1UL)** | 520d | 2022-06-15 A | 2024-06-06 | 70% | 155.9d | 453d |  |  | 8312h |  | DC_R18_1BLTE_1BNR_2DL2UL | 49 | CHTTL | Rel-18 | 96 |  |  |  |  |
| 981 | 467.1 | Core part: Rel-18 Dual Connectivity (DC) of 1 band LTE (1DL/1UL) and 1 NR band (1DL/1UL) | 520d | 2022-06-15 A | 2024-06-06 | 90% | 52d | 453d | finish no earlier than 2024-06-06 | R4 | 4160h |  | DC_R18_1BLTE_1BNR_2DL2UL-Core | 49 | Bo-Han Hsieh (Tank), CHTTL | Rel-18 | 96 | 37.718-11-11 | pohanhsieh@cht.com.tw | RP-240481 |  |
| 982 | 467.2 | Perf. part: Rel-18 Dual Connectivity (DC) of 1 band LTE (1DL/1UL) and 1 NR band (1DL/1UL) | 519d | 2022-06-16 A | 2024-06-06 | 50% | 259.5d | 453d | finish no earlier than 2024-06-06 | R4 | 4152h |  | DC_R18_1BLTE_1BNR_2DL2UL-Perf | 49 | Bo-Han Hsieh (Tank), CHTTL | Rel-18 | 96 |  | pohanhsieh@cht.com.tw | RP-240481 |  |
| 983 | 468 | **Rel-18 Dual Connectivity (DC) of x LTE bands and y NR bands with z bands DL and 3 bands UL (x=1, 2, 3, 4; y=1, 2; 3<=z<=6)** | 520d | 2022-06-15 A | 2024-06-06 | 78% | 114.14d | 453d |  |  | 7752h |  | DC_R18_xBLTE_yBNR_zDL3UL | 49 | Samsung | Rel-18 | 96 |  |  |  |  |
| 984 | 468.1 | Core part: Rel-18 Dual Connectivity (DC) of x LTE bands and y NR bands with z bands DL and 3 bands UL (x=1, 2, 3, 4; y=1, 2; 3<=z<=6) | 520d | 2022-06-15 A | 2024-06-06 | 85% | 78d | 453d | finish no earlier than 2024-06-06 | R4 | 4160h |  | DC_R18_xBLTE_yBNR_zDL3UL-Core | 49 | Yuanyuan Zhang, Samsung | Rel-18 | 96 |  | Tina55.zhang@samsung.com | RP-240373 |  |
| 985 | 468.2 | Perf. part: Rel-18 Dual Connectivity (DC) of x LTE bands and y NR bands with z bands DL and 3 bands UL (x=1, 2, 3, 4; y=1, 2; 3<=z<=6) | 449d | 2022-06-15 A | 2024-03-01 | 70% | 134.7d | 524d | finish no earlier than 2024-03-01 | R4 | 3592h |  | DC_R18_xBLTE_yBNR_zDL3UL-Perf | 49 | Yuanyuan Zhang, Samsung | Rel-18 | 96 |  | Tina55.zhang@samsung.com | RP-240373 |  |
| 986 | 469 | **Rel-18 Dual Connectivity (DC) of x bands (x=1,2,3,4) LTE inter-band CA (xDL/1UL) and 2 bands NR inter-band CA (2DL/1UL)** | 520d | 2022-06-15 A | 2024-06-06 | 93% | 39d | 453d |  |  | 8320h | 4160h | DC_R18_xBLTE_2BNR_yDL2UL | 49 | LG Electronics | Rel-18 | 96 |  |  |  |  |
| 987 | 469.1 | Core part: Rel-18 Dual Connectivity (DC) of x bands (x=1,2,3,4) LTE inter-band CA (xDL/1UL) and 2 bands NR inter-band CA (2DL/1UL) | 520d | 2022-06-15 A | 2024-06-06 | 85% | 78d | 453d | finish no earlier than 2024-06-06 | R4 | 4160h |  | DC_R18_xBLTE_2BNR_yDL2UL-Core | 49 | Sang-Wook Lee, LG Electronics | Rel-18 | 96 | 37.718-11-21 | sangwook1.lee@lge.com | RP-240325 |  |
| 988 | 469.2 | Stopped - Perf. Part: Rel-18 Dual Connectivity (DC) of x bands (x=1,2,3,4) LTE inter-band CA (xDL/1UL) and 2 bands NR inter-band CA (2DL/1UL) | 520d | 2022-06-15 A | 2024-06-06 A | 100% |  |  | finish no earlier than 2024-06-06 | R4 | 4160h | 4160h | DC_R18_xBLTE_2BNR_yDL2UL-Perf | 49 | Sang-Wook Lee, LG Electronics | Rel-18 | 96 |  | sangwook1.lee@lge.com | RP-240325 |  |
| 989 | 470 | **Rel-18 Dual Connectivity (DC) of 2 bands LTE inter-band CA (2DL/1UL) and 1 NR band (1DL/1UL)** | 520d | 2022-06-15 A | 2024-06-06 | 95% | 27.91d | 453d |  |  | 7752h | 3592h | DC_R18_2BLTE_1BNR_3DL2UL | 49 | Huawei | Rel-18 | 96 |  |  |  |  |
| 990 | 470.1 | Core part: Rel-18 Dual Connectivity (DC) of 2 bands LTE inter-band CA (2DL/1UL) and 1 NR band (1DL/1UL) | 520d | 2022-06-15 A | 2024-06-06 | 90% | 52d | 453d | finish no earlier than 2024-06-06 | R4 | 4160h |  | DC_R18_2BLTE_1BNR_3DL2UL-Core | 49 | Liehai Liu, Huawei | Rel-18 | 96 | 37.718-21-11 | liuliehai@huawei.com | RP-240415 |  |
| 991 | 470.2 | Stopped - Perf. part: Rel-18 Dual Connectivity (DC) of 2 bands LTE inter-band CA (2DL/1UL) and 1 NR band (1DL/1UL) | 449d | 2022-06-15 A | 2024-03-01 A | 100% |  |  | finish no earlier than 2024-03-01 | R4 | 3592h | 3592h | DC_R18_2BLTE_1BNR_3DL2UL-Perf | 49 | Liehai Liu, Huawei | Rel-18 | 96 |  | liuliehai@huawei.com | RP-233192 | 102 |
| 992 | 471 | **Rel-18 Dual Connectivity (DC) of x bands (x=3,4,5) LTE inter-band CA (xDL/1UL) and 1 NR band (1DL/1UL)** | 520d | 2022-06-15 A | 2024-06-06 | 95% | 27.91d | 453d |  |  | 7752h | 3592h | DC_R18_xBLTE_1BNR_yDL2UL | 49 | Nokia | Rel-18 | 96 |  |  |  |  |
| 993 | 471.1 | Core part: Rel-18 Dual Connectivity (DC) of x bands (x=3,4,5) LTE inter-band CA (xDL/1UL) and 1 NR band (1DL/1UL) | 520d | 2022-06-15 A | 2024-06-06 | 90% | 52d | 453d | finish no earlier than 2024-06-06 | R4 | 4160h |  | DC_R18_xBLTE_1BNR_yDL2UL-Core | 49 | Johannes Hejselbaek, Nokia | Rel-18 | 96 |  | johannes.hejselbaek@nokia.com | RP-240382 |  |
| 994 | 471.2 | Perf. part: Rel-18 Dual Connectivity (DC) of x bands (x=3,4,5) LTE inter-band CA (xDL/1UL) and 1 NR band (1DL/1UL) | 449d | 2022-06-15 A | 2024-03-01 A | 100% |  |  | finish no earlier than 2024-03-01 | R4 | 3592h | 3592h | DC_R18_xBLTE_1BNR_yDL2UL-Perf | 49 | Johannes Hejselbaek, Nokia | Rel-18 | 96 |  | johannes.hejselbaek@nokia.com | RP-240382 |  |
| 995 | 472 | **Rel-18 Dual Connectivity (DC) of x bands (x=1,2,3) LTE inter-band CA (xDL/1UL) and y bands (3<=y<=5 and x+y <= 6) NR inter-band CA (yDL/1UL)** | 520d | 2022-06-15 A | 2024-06-06 | 95% | 27.91d | 453d |  |  | 7752h | 3592h | DC_R18_xBLTE_yBNR_zDL2UL | 49 | ZTE | Rel-18 | 96 |  |  |  |  |
| 996 | 472.1 | Core part: Rel-18 Dual Connectivity (DC) of x bands (x=1,2,3) LTE inter-band CA (xDL/1UL) and y bands (3<=y<=5 and x+y <= 6) NR inter-band CA (yDL/1UL) | 520d | 2022-06-15 A | 2024-06-06 | 90% | 52d | 453d | finish no earlier than 2024-06-06 | R4 | 4160h |  | DC_R18_xBLTE_yBNR_zDL2UL-Core | 49 | Wubin Zhou, ZTE | Rel-18 | 96 |  | Zhou.wubin@zte.com.cn | RP-240250 |  |
| 997 | 472.2 | Stopped - Perf. part: Rel-18 Dual Connectivity (DC) of x bands (x=1,2,3) LTE inter-band CA (xDL/1UL) and y bands (3<=y<=5 and x+y <= 6) NR inter-band CA (yDL/1UL) | 449d | 2022-06-15 A | 2024-03-01 A | 100% |  |  | finish no earlier than 2024-03-01 | R4 | 3592h | 3592h | DC_R18_xBLTE_yBNR_zDL2UL-Perf | 49 | Wubin Zhou, ZTE | Rel-18 | 96 |  | Zhou.wubin@zte.com.cn | RP-240250 |  |

Notes:
- 974: 9/1/23: WID:RP-222669->RP-223112; 2/1/24: WID:RP-223112->RP-234064
- 975: 9/12/22: FCD:10/12/2023->01/12/2023; Compl:0%->15%; Stat Rep: ->RP-223111; Rapporteur: Vivo->Wang, Ruixin, vivo; Rap eMail: ->ruixin.wang@vivo.com; 17/3/23: FCD:30/11/2023->12/12/2023; Compl:15%->30%; Stat Rep: RP-223111->RP-230375; 17/3/23: 38.87...;...; 14/3/24: Stat Rep: RP-233073->RP-240137;
- 976: 9/12/22: FCD:10/06/2024->01/06/2024; Stat Rep: ->RP-223111; Rapporteur: Vivo->Wang, Ruixin, vivo; Rap eMail: ->ruixin.wang@vivo.com; 17/3/23: Compl:0%->5%; Stat Rep: RP-223111->RP-230375; ;...; 6/9/23: FCD:06/06/2023->06/06/2024; Compl:20%->30%; Stat ...; 14/3/24: FCD:05/06/2024->06/06/2024; Compl:50%->75%; Stat Rep: RP-233073->RP-240137;
- 977: 23/9/22: WID:RP-221839->RP-222507; 9/1/23: WID:RP-222507->RP-223537; 29/3/23: WID:RP-223537->RP-230475; 6/10/23: WID:RP-230475->RP-232372; 2/1/24: WID:RP-232372->RP-233197; 2/4/24: WID:RP-233197->RP-240420
- 978: 9/9/22: Comp...; 23/9/22: 37.718-00-00 added;; 9/12/22: FCD:23/12/2022->01/12/2023; Compl:10%->20%; Stat Rep: ->RP-223349; Rapporteur: Huawei->Zhang, Peng, Huawei; Rap eMail: ->zhangpeng169@huawei.com; 17/3/23: FCD:30/11/2023->12/12/2023.....; 14/3/24: FCD:01/03/2024->06/06/2024; Compl:80%->90%; Stat Rep: RP-233195->RP-240418;
- 979: 9/9/22: Comp...; 9/12/22: FCD:23/12/2022->01/12/2023; Compl:10%->20%; Stat Rep: ->RP-223349; Rapporteur: Huawei->Zhang, Peng, Huawei; Rap eMail: ->zhangpeng169@huawei.com; 17/3/23: FCD:30/11/2023->12/12/2023; Compl:20%->40%; Stat Rep: RP.....; 2/4/24: Stopped at 90%
- 980: 23/9/22: WID:RP-221264->RP-222091; 9/1/23: WID:RP-222091->RP-223078; 29/3/23: WID:RP-223078->RP-230338; 6/10/23: WID:RP-230338->RP-232302; 2/1/24: WID:RP-232302->RP-233242; 2/4/24: WID:RP-233242->RP-240482
- 981: 9/9/22: Comp...; 23/9/22: 37.718-11-11 added;; 9/12/22: FCD:23/12/2022->01/12/2023; Compl:5%->15%; WID: RP-222091->RP-222091 Revised WID: Rel-18 Dual Connectivity (DC) of 1 band LTE (1DL/1UL) and 1 NR band (1DL/1UL); Stat Rep: ->RP-223077;...; 14/3/24: FCD:01/03/2024->06/06/2024; Compl:85%->90%; WID: RP-233242->RP-233242 Revised WID: Rel-18 Dual Connectivity (DC) of 1 band LTE (1DL/1UL) and 1 NR band (1DL/1UL); Stat Rep: RP-233240->RP-240481;
- 982: 9/9/22: CD:1...; 9/12/22: FCD:23/12/2022->01/12/2023; WID: RP-222091->RP-222091 Revised WID: Rel-18 Dual Connectivity (DC) of 1 band LTE (1DL/1UL) and 1 NR band (1DL/1UL); Stat Rep: ->RP-223077; Rapporteur: CHTTL->Bo-Han Hsieh (Tank), CHTT...; 14/3/24: FCD:03/03/2024->06/06/2024; Compl:0%->50%; WID: RP-233242->RP-233242 Revised WID: Rel-18 Dual Connectivity (DC) of 1 band LTE (1DL/1UL) and 1 NR band (1DL/1UL); Stat Rep: RP-233240->RP-240481;
- 983: 23/9/22: WID:RP-221400->RP-222237; 2/1/24: WID:RP-222237->RP-233989; 2/4/24: WID:RP-233989->RP-240374
- 984: 9/9/22: Comp...; 9/12/22: FCD:23/12/2022->01/12/2023; Compl:5%->15%; Stat Rep: ->RP-222924; Rapporteur: Samsung->Yuanyuan Zhang, Samsung; Rap eMail: ->Tina55.zhang@samsung.com; 17/3/23: FCD:30/11/2023->12/12/2023; Compl:15%->30%; Stat Re.....; 14/3/24: FCD:01/03/2024->06/06/2024; Compl:70%->85%; Stat Rep: RP-233143->RP-240373;
- 985: 9/9/22: Comp...; 9/12/22: FCD:23/12/2022->01/12/2023; Compl:5%->15%; Stat Rep: ->RP-222924; Rapporteur: Samsung->Yuanyuan Zhang, Samsung; Rap eMail: ->Tina55.zhang@samsung.com; 17/3/23: FCD:30/11/2023->12/12/2023; Compl:15%->30%; Stat Re.....; 14/3/24: Stat Rep: RP-233143->RP-240373;
- 986: 23/9/22: WID:RP-221800->RP-221944; 9/1/23: WID:RP-221944->RP-222840; 29/3/23: WID:RP-222840->RP-230725; 6/10/23: WID:RP-230725->RP-231723; 2/1/24: WID:RP-231723->RP-233488; 2/4/24: WID:RP-233488->RP-240758
- 987: 9/9/22: Comp...; 23/9/22: 37.718-11-21 added;; 9/12/22: FCD:23/12/2022->01/12/2023; Compl:5%->15%; Stat Rep: ->RP-222841; Rapporteur: LG Electronics->Sang-Wook Lee, LG Electronics; Rap eMail: ->sangwook1.lee@lge.com; 17/3/23: FCD:30/11/2.....; 14/3/24: FCD:01/03/2024->06/06/2024; Compl:80%->85%; Stat Rep: RP-233489->RP-240325;
- 988: 9/9/22: Comp...; 9/12/22: FCD:23/12/2022->01/12/2023; Compl:5%->15%; Stat Rep: ->RP-222841; Rapporteur: LG Electronics->Sang-Wook Lee, LG Electronics; Rap eMail: ->sangwook1.lee@lge.com; 17/3/23: FCD:30/11/2023->12/12/2023; Compl:15%->30.....; 2/4/24: stopped at 85%
- 989: 23/9/22: WID:RP-221832->RP-222505; 9/1/23: WID:RP-222505->RP-223348; 29/3/23: WID:RP-223348->RP-230473; 6/10/23: WID:RP-230473->RP-232370; 2/1/24: WID:RP-232370->RP-233987; 2/4/24: WID:RP-233987->RP-240417
- 990: 9/9/22: Comp...; 23/9/22: 37.718-21-11 added;; 9/12/22: FCD:23/12/2022->01/12/2023; Compl:10%->30%; Stat Rep: ->RP-223347; Rapporteur: Huawei->Liehai Liu, Huawei; Rap eMail: ->liuliehai@huawei.com; 17/3/23: FCD:30/11/2023->12/12/2023; Co.....; 14/3/24: FCD:01/03/2024->06/06/2024; Compl:85%->90%; Stat Rep: RP-233192->RP-240415;
- 991: 9/9/22: Comp…; 9/12/22: FCD:23/12/2022->01/12/2023; Compl:10%->30%; Stat Rep: ->RP-223347; Rapporteur: Huawei->Liehai Liu, Huawei; Rap eMail: ->liuliehai@huawei.com; 17/3/23: FCD:30/11/2023->12/12/2023; Compl:30%->50%¦01/24: stopped at 85% at RAN#102
- 992: 23/9/22: WID:RP-221833->RP-222312; 9/1/23: WID:RP-222312->RP-222876; 29/3/23: WID:RP-222876->RP-230090; 6/10/23: WID:RP-230090->RP-232248; 2/1/24: WID:RP-232248->RP-233988; 2/4/24: WID:RP-233988->RP-240384
- 993: 9/9/22: Comp...; 9/12/22: FCD:23/12/2022->01/12/2023; Compl:5%->15%; Stat Rep: ->RP-222875; Rapporteur: Nokia->Johannes Hejselbaek, Nokia; Rap eMail: ->johannes.hejselbaek@nokia.com; 17/3/23: FCD:30/11/2023->12/12/2023; Compl:15%->25%; S.....; 14/3/24: FCD:01/03/2024->06/06/2024; Compl:70%->90%; Stat Rep: RP-233648->RP-240382;
- 994: 9/9/22: Comp...; 9/12/22: FCD:23/12/2022->01/12/2023; Stat Rep: ->RP-222875; Rapporteur: Nokia->Johannes Hejselbaek, Nokia; Rap eMail: ->johannes.hejselbaek@nokia.com; 17/3/23: FCD:30/11/2023->12/12/2023; Compl:5%->10%; Stat Rep: RP-2228.....; 14/3/24: Compl:80%->100%; Stat Rep: RP-233648->RP-240382;
- 995: 23/9/22: WID:RP-221834->RP-222094; 9/1/23: WID:RP-222094->RP-222906; 29/3/23: WID:RP-222906->RP-230135; 6/10/23: WID:RP-230135->RP-231842; 2/1/24: WID:RP-231842->RP-232923; 2/4/24: WID:RP-232923->RP-240760
- 996: 9/9/22: Comp...; 9/12/22: FCD:23/12/2022->01/12/2023; Compl:5%->20%; Stat Rep: ->RP-222907; Rapporteur: ZTE->Aijun Cao, ZTE; Rap eMail: ->Cao.aijun@zte.com.cn; 17/3/23: FCD:30/11/2023->12/12/2023; Compl:20%->40%; Stat Rep: RP-222907->RP-.....; 14/3/24: FCD:01/03/2024->06/06/2024; Compl:85%->90%; Stat Rep: RP-232925->RP-240250;
- 997: 9/9/22: Comp...; 9/12/22: FCD:23/12/2022->01/12/2023; Compl:5%->20%; Stat Rep: ->RP-222907; Rapporteur: ZTE->Aijun Cao, ZTE; Rap eMail: ->Cao.aijun@zte.com.cn; 17/3/23: FCD:30/11/2023->12/12/2023; Compl:20%->40%; Stat Rep: RP-222907->RP-.....; 2/4/24: Stopped at 85%

| ID | WBS | Task | Type | Duration | Start | Finish | Complete | Remaining | Total slack | Constraint | Resources | Work | Actual work | Acronym | PCG approved | WI rapporteur name | Release | TSG approved | Impacted TSs and TRs | WI rapporteur e-mail | Status Report | TSG stopped |
| --- | --- | --- | --- | --- | --- | --- | --- | --- | --- | --- | --- | --- | --- | --- | --- | --- | --- | --- | --- | --- | --- | --- |
| 998 | 473 | **Rel-18 band combinations for concurrent operation of NR/LTE Uu bands/band combinations and one NR/LTE V2X PC5 band** |  | 391d | 2022-06-15 A | 2023-12-12 A | 100% |  |  |  |  | 6256h | 6256h | NR_LTE_V2X_PC5_combos_R18 | 49 | CATT | Rel-18 | 96 |  |  |  |  |
| 999 | 473.1 | Core part: Rel-18 band combinations for concurrent operation of NR/LTE Uu bands/band combinations and one NR/LTE V2X PC5 band |  | 391d | 2022-06-15 A | 2023-12-12 A | 100% |  |  | finish no earlier than 2023-12-12 | R4 | 3128h | 3128h | NR_LTE_V2X_PC5_combos_R18-Core | 49 | Qiuge Guo, CATT | Rel-18 | 96 | 37.878 | guoqiuge@catt.cn | RP-233006 |  |
| 1000 | 473.2 | Perf. part: Rel-18 band combinations for concurrent operation of NR/LTE Uu bands/band combinations and one NR/LTE V2X PC5 band |  | 391d | 2022-06-15 A | 2023-12-12 A | 100% |  |  | finish no earlier than 2023-12-12 | R4 | 3128h | 3128h | NR_LTE_V2X_PC5_combos_R18-Perf | 49 | Qiuge Guo, CATT | Rel-18 | 96 |  | guoqiuge@catt.cn | RP-233006 |  |
| 1001 | 474 | **Rel-18 downlink interruption for NR and EN-DC band combinations at dynamic Tx Switching in Uplink** |  | 391d | 2022-06-15 A | 2023-12-12 A | 100% |  |  |  |  | 6256h | 6256h | DL_intrpt_combos_TxSW_R18 | 49 | China Telecom | Rel-18 | 96 |  | LTE, NR |  |  |
| 1002 | 474.1 | Core part: Rel-18 downlink interruption for NR and EN-DC band combinations at dynamic Tx Switching in Uplink |  | 391d | 2022-06-15 A | 2023-12-12 A | 100% |  |  | finish no earlier than 2023-12-12 | R4 | 3128h | 3128h | DL_intrpt_combos_TxSW_R18-Core | 49 | Liu, Bo, China Telecom | Rel-18 | 96 | 37.877 | liubo1@chinatelecom.cn | RP-233587 |  |
| 1003 | 474.2 | Perf. part: Rel-18 downlink interruption for NR and EN-DC band combinations at dynamic Tx Switching in Uplink |  | 391d | 2022-06-15 A | 2023-12-12 A | 100% |  |  | finish no earlier than 2023-12-12 | R4 | 3128h | 3128h | DL_intrpt_combos_TxSW_R18-Perf | 49 | Liu, Bo, China Telecom | Rel-18 | 96 |  | liubo1@chinatelecom.cn | RP-233587 |  |
| 1004 | 475 | Rel-18 Other LTE-only | milestone | 0d? | 2019-03-07 | 2019-03-07 |  |  | 1828d |  |  |  |  |  |  |  | Rel-18 |  |  |  |  |  |
| 1005 | 476 | **High Power UE (Power Class 2) for LTE FDD Band 14** |  | 126d | 2023-09-09 A | 2024-03-01 A | 100% |  |  |  | R4 | 3024h | 3024h | HPUE_LTE_FDD_B14 | 51 | AT&T | Rel-18 | 101 |  |  |  |  |
| 1006 | 476.1 | Core part: High Power UE (Power Class 2) for LTE FDD Band 14 |  | 126d | 2023-09-09 A | 2024-03-01 A | 100% |  |  | finish no earlier than 2024-03-01 | R4 | 1008h | 1008h | HPUE_LTE_FDD_B14-Core | 51 | Borsato, Ron | Rel-18 | 101 | 36.77 | ronald.borsato@att.com | RP-240075 |  |
| 1007 | 476.2 | Perf. part: High Power UE (Power Class 2) for LTE FDD Band 14 |  | 126d | 2023-09-09 A | 2024-03-01 A | 100% |  |  | finish no earlier than 2024-03-01 | R4 | 1008h | 1008h | HPUE_LTE_FDD_B14-Perf | 51 | Borsato, Ron | Rel-18 | 101 |  | ronald.borsato@att.com | RP-240075 |  |
| 1008 | 477 | **Additional LTE bands for UE categories M1/M2/NB1/NB2 in Rel-18** |  | 262d | 2022-12-13 A | 2023-12-12 A | 100% |  |  |  |  | 4192h | 4192h | LTE_bands_R18_M1_M2_NB1_NB2 | 50 | Ericsson | Rel-18 | 98 |  |  |  |  |
| 1009 | 477.1 | Core part: Additional LTE bands for UE categories M1/M2/NB1/NB2 in Rel-18 |  | 262d | 2022-12-13 A | 2023-12-12 A | 100% |  |  | finish no earlier than 2023-12-12 | R4 | 2096h | 2096h | LTE_bands_R18_M1_M2_NB1_NB2-Core | 50 | Chunhui Zhang, Ericsson | Rel-18 | 98 |  | Chunhui.Zhang@ericsson.com | RP- 232891 |  |
| 1010 | 477.2 | Perf. part: Additional LTE bands for UE categories M1/M2/NB1/NB2 in Rel-18 |  | 262d | 2022-12-13 A | 2023-12-12 A | 100% |  |  | finish no earlier than 2023-12-12 | R4 | 2096h | 2096h | LTE_bands_R18_M1_M2_NB1_NB2-Perf | 50 | Chunhui Zhang, Ericsson | Rel-18 | 98 |  | Chunhui.Zhang@ericsson.com | RP- 232891 |  |
| 1011 | 478 | **Introduction of 900 MHz LTE band in the US** |  | 584d | 2022-12-12 A | 2025-03-03 | 27% | 426.2d | 261d |  |  | 4136h | 1016h | LTE_900MHz_US | 50 | Anterix | Rel-18 | 98 |  |  |  |  |
| 1012 | 478.1 | Core part: Introduction of 900 MHz LTE band in the US |  | 127d | 2022-12-12 A | 2023-06-06 A | 100% |  |  | finish no earlier than 2023-06-06 | R4 | 1016h | 1016h | LTE_900MHz_US-Core | 50 | Emil Olbrich, Anterix | Rel-18 | 98 |  | eolbrich@anterix.com | RP-231218 |  |
| 1013 | 478.2 | Perf. part: Introduction of 900 MHz LTE band in the US |  | 127d | 2022-12-12 A | 2023-06-06 | 10% | 114.3d | 718d | finish no earlier than 2023-06-06 | R4 | 1016h |  | LTE_900MHz_US-Perf | 50 | Emil Olbrich, Anterix | Rel-18 | 98 |  | eolbrich@anterix.com | RP-231218 |  |
| 1014 | 478.3 | UE Conformance - Introduction of 900 MHz LTE band in the US |  | 263d | 2024-03-03 | 2025-03-03 |  |  | 261d | finish no earlier than 2025-03-03 | R5 | 2104h |  | LTE_900MHz_US-UEConTest |  | Nokia | Rel-18 |  |  |  |  |  |
| 1015 | 479 | **Maximum Power Reduction Requirements (MPR) for LTE intra-band Carrier Aggregation (CA) with a Component Carrier (CC) gap larger than 35 MHz** |  | 60d | 2022-12-12 A | 2023-03-03 A | 100% |  |  |  |  | 480h | 480h | LTE_intra_CA_MPR_35MHz_gap | 50 | Huawei | Rel-18 | 98 |  |  |  |  |
| 1016 | 479.1 | Core part: Maximum Power Reduction Requirements (MPR) for LTE intra-band Carrier Aggregation (CA) with a Component Carrier (CC) gap larger than 35 MHz |  | 60d | 2022-12-12 A | 2023-03-03 A | 100% |  |  | finish no earlier than 2023-03-03 | R4 | 480h | 480h | LTE_intra_CA_MPR_35MHz_gap-Core | 50 | Mohammad Abdi Abyaneh, Huawei, HiSilicon | Rel-18 | 98 |  | Mohammad.abdi.abyaneh@huawei.com | RP-230480 |  |
| 1017 | 480 | **Rel-18 LTE-Advanced Carrier Aggregation for x bands (2<=x<= 6) DL with y bands (y=1, 2) UL** |  | 520d | 2022-06-15 A | 2024-06-06 | 76% | 125.57d | 453d |  |  | 7752h | 3592h | LTE_CA_R18_xBDL_yBUL | 49 | Huawei | Rel-18 | 96 |  | LTE |  |  |
| 1018 | 480.1 | Core part: Rel-18 LTE-Advanced Carrier Aggregation for x bands (2<=x<= 6) DL with y bands (y=1, 2) UL |  | 520d | 2022-06-15 A | 2024-06-06 | 55% | 234d | 453d | finish no earlier than 2024-06-06 | R4 | 4160h |  | LTE_CA_R18_xBDL_yBUL-Core | 49 | Mohammad Abdi Abyaneh, Huawei- HiSilicon | Rel-18 | 96 | 36.718-02-01 | Mohammad.abdi.abyaneh@huawei.com | RP-240412 |  |
| 1019 | 480.2 | Stopped - Perf. part: Rel-18 LTE-Advanced Carrier Aggregation for x bands (2<=x<= 6) DL with y bands (y=1, 2) UL |  | 449d | 2022-06-15 A | 2024-03-01 A | 100% |  |  | finish no earlier than 2024-03-01 | R4 | 3592h | 3592h | LTE_CA_R18_xBDL_yBUL-Perf | 49 | Mohammad Abdi Abyaneh, Huawei- HiSilicon | Rel-18 | 96 |  | Mohammad.abdi.abyaneh@huawei.com | RP-233189 | 102 |
| 1020 | 481 | **LTE intra-band contiguous Carrier Aggregation for band 8** |  | 137d | 2022-06-15 A | 2022-12-22 A | 100% |  |  |  | R4 | 2192h | 2192h | LTE_CA_intra_B8 | 49 | China Mobile | Rel-18 | 96 |  | LTE |  |  |
| 1021 | 481.1 | Core part: LTE intra-band contiguous Carrier Aggregation for band 8 |  | 137d | 2022-06-15 A | 2022-12-22 A | 100% |  |  | finish no earlier than 2022-12-22 | R4 | 1096h | 1096h | LTE_CA_intra_B8-Core | 49 | China Mobile | Rel-18 | 96 |  | LTE |  |  |

Notes:
- 998: 23/9/22: WID:RP-221879->RP-222385; 29/3/23: WID:RP-222385->RP-230390
- 999: 9/9/22: Comp...; 23/9/22: 37.878 added;; 17/3/23: FCD:23/12/2022->12/12/2023; Compl:5%->50%; Stat Rep: ->RP-230389; Rapporteur: CATT->Qiuge Guo, CATT; Rap eMail: ->guoqiuge@catt.cn; ; 6/9/23: Stat Rep: RP-230389->RP-231834; ; 8/12/23: Compl:50%->100%; Stat Rep: RP-231834->RP-233006;
- 1000: 9/9/22: CD:1...; 9/12/22: Acronym:NR_LTE_V2X_PC5_combos_R18-Perf->NR_LTE_V2X_PC5_combos_R18-Core; FCD:23/12/2022->01/12/2023; Compl:0%->50%; Stat Rep: ->RP-223146; Rapporteur: CATT->Qiuge Guo, CATT; Rap eMail: ->guoqiuge@catt.cn; 17/3/23.....; 8/12/23: Compl:0%->100%; Stat Rep: RP-231834->RP-233006;
- 1001: 23/9/22: WID:RP-221843->RP-222288; 2/1/24: WID:RP-222288->RP-233588
- 1002: 9/9/22: Comp...; 23/9/22: 37.877 added;; 17/3/23: FCD:23/12/2022->12/12/2023; Compl:10%->99%; WID: RP-222288->RP-221843 RP-222288; Stat Rep: ->RP-230319; Rapporteur: China Telecom->Liu, Bo, China Telecom; Rap eMail: LTE, NR->liubo1@chinate...; 8/12/23: Compl:99%->100%; Stat Rep: RP-232269->RP-233587;
- 1003: 9/9/22: CD:1...; 9/12/22: Acronym:DL_intrpt_combos_TxSW_R18-Perf->DL_intrpt_combos_TxSW_R18-Core; FCD:23/12/2022->01/12/2023; Compl:0%->20%; WID: RP-222288->RP-221843 RP-222288; Stat Rep: ->RP-222939; Rapporteur: China Telecom->Liu, Bo, Ch...; 8/12/23: Compl:0%->100%; Stat Rep: RP-232269->RP-233587;
- 1004: -
- 1005: 2/1/24: WID:RP-232676->RP-232946
- 1006: 8/12/23: FCD:12/12/2023->01/03/2024; Compl:0%->50%; Stat Rep: ->RP-232945; Rapporteur: AT&T->Borsato, Ron; Rap eMail: ->ronald.borsato@att.com; ; 4/1/24: 36.770 added;; 14/3/24: Compl:50%->100%; Stat Rep: RP-232945->RP-240075; List of Impacted TS & TR updated;
- 1007: 8/12/23: FCD:12/12/2023->01/03/2024; Compl:0%->80%; Stat Rep: ->RP-232945; Rapporteur: AT&T->Borsato, Ron; Rap eMail: ->ronald.borsato@att.com; ; 14/3/24: Compl:80%->100%; Stat Rep: RP-232945->RP-240075;
- 1008: 2/1/24: WID:RP-222824->RP-232892
- 1009: 17/3/23: Compl:0%->99%; Stat Rep: ->RP-230462; Rapporteur: Ericsson->Chunhui Zhang, Ericsson; Rap eMail: ->Chunhui.Zhang@ericsson.com; ; 6/9/23: Stat Rep: RP-230462->RP-231880; ; 8/12/23: Compl:99%->100%; Stat Rep: RP-231880->RP- 232891;
- 1010: 17/3/23: Compl:0%->99%; Stat Rep: ->RP-230462; Rapporteur: Ericsson->Chunhui Zhang, Ericsson; Rap eMail: ->Chunhui.Zhang@ericsson.com; ; 6/9/23: Stat Rep: RP-230462->RP-231880; ; 8/12/23: Compl:99%->100%; Stat Rep: RP-231880->RP- 232891;
- 1011: 29/3/23: WID:RP-223530->RP-230722
- 1012: 17/3/23: Compl:0%->20%; Stat Rep: ->RP-230264; Rapporteur: Anterix->Emil Olbrich, Anterix; Rap eMail: ->eolbrich@anterix.com; ; 29/6/23: 20%->100
- 1013: 17/3/23: Compl:0%->10%; Stat Rep: ->RP-230264; Rapporteur: Anterix->Emil Olbrich, Anterix; Rap eMail: ->eolbrich@anterix.com;
- 1015: 29/3/23: WID:RP-223511->RP-230705
- 1016: 17/3/23: FCD:06/06/2023->03/03/2023; Compl:0%->100%; Stat Rep: ->RP-230480; Rapporteur: Huawei->Mohammad Abdi Abyaneh, Huawei, HiSilicon; Rap eMail: ->Mohammad.abdi.abyaneh@huawei.com;
- 1017: 23/9/22: WID:RP-221831->RP-222503; 9/1/23: WID:RP-222503->RP-223489; 29/3/23: WID:RP-223489->RP-230471; 6/10/23: WID:RP-230471->RP-232368; 2/1/24: WID:RP-232368->RP-233927; 2/4/24: WID:RP-233927->RP-240414
- 1018: 9/9/22: Comp...; 23/9/22: 36.718-02-01 added;; 9/12/22: FCD:23/12/2022->01/12/2023; Compl:20%->35%; Stat Rep: ->RP-223345; Rapporteur: Huawei->Mohammad Abdi Abyaneh, Huawei; Rap eMail: LTE->Mohammad.abdi.abyaneh@huawei.com; 17/3/23: FCD:.....; 14/3/24: FCD:01/03/2024->06/06/2024; Compl:43%->55%; Stat Rep: RP-233189->RP-240412;
- 1019: 9/9/22: Comp...; 9/12/22: FCD:23/12/2022->01/12/2023; Compl:20%->35%; Stat Rep: ->RP-223345; Rapporteur: Huawei->Mohammad Abdi Abyaneh, Huawei; Rap eMail: LTE->Mohammad.abdi.abyaneh@huawei.com; 17/3/23: FCD:30/11/2023->12/12/2023; Stat R.....; 2/1/24: Stopped at 43% at RAN#102
- 1021: 9/9/22: Comp...; 9/1/23: 99%->100

| ID | WBS | Task | Type | Duration | Start | Finish | Complete | Remaining | Total slack | Constraint | Resources | Work | Actual work | Acronym | PCG approved | Release | TSG approved | Status Report |
| --- | --- | --- | --- | --- | --- | --- | --- | --- | --- | --- | --- | --- | --- | --- | --- | --- | --- | --- |
| 1022 | 482 | **Introduction of 600MHz US LTE band with 1.4 and 3MHz channel bandwidths** |  | 204d | 2023-03-03 A | 2023-12-12 |  | 204d | 582d |  | R4 | 4896h | 1632h | LTE600_US_lowCBW | 50 | Rel-18 | 99 |  |
| 1023 | 482.1 | Core part: Introduction of 600MHz US LTE band with 1.4 and 3MHz channel bandwidths |  | 204d | 2023-03-03 | 2023-12-12 |  |  | 582d | finish no earlier than 2023-12-12 | R4 | 1632h |  | LTE600_US_lowCBW-Core | 50 | Rel-18 | 99 |  |
| 1024 | 482.2 | Perf. part: Introduction of 600MHz US LTE band with 1.4 and 3MHz channel bandwidths |  | 204d | 2023-03-03 | 2023-12-12 |  |  | 582d | finish no earlier than 2023-12-12 | R4 | 1632h |  | LTE600_US_lowCBW-Perf | 50 | Rel-18 | 99 |  |
| 1025 | 483 | Rel-18 RAN Studies | milestone | 0d? | 2017-12-15 A | 2017-12-15 | 34% | 0d? | 2147d |  |  |  |  |  |  | Rel-18 |  |  |
| 1026 | 484 | Study on enhancement for sub-1GHz NR band combinations |  | 136d | 2023-03-03 A | 2023-09-08 A | 100% |  |  | finish no earlier than 2023-09-08 | R4 | 1088h | 1088h | FS_NR_sub1GHz_combo_enh | 50 | Rel-18 | 99 | RP-232661 |
| 1027 | 485 | Study on self-evaluation towards the IMT-2020 submission of the 3GPP Satellite Radio Interface Technology |  | 204d | 2023-03-03 A | 2023-12-12 A | 100% |  |  | finish no earlier than 2023-12-12 | RP | 1632h | 1632h | FS_IMT2020_SAT_eval | 50 | Rel-18 | 99 | RP-231944 |
| 1028 | 486 | Study on Ambient IoT (Internet of Things) in RAN |  | 262d | 2022-09-08 A | 2023-09-08 A | 100% |  |  | finish no earlier than 2023-09-08 | RP | 2096h | 2096h | FS_Ambient_IoT_RAN | 49 | Rel-18 | 97 | RP-232403 |
| 1029 | 487 | Study on simplification of band combination specification for NR and LTE |  | 457d | 2022-03-15 A | 2023-12-12 A | 100% |  |  | finish no earlier than 2023-12-12 | R4 | 3656h | 3656h | FS_SimBC | 48 | Rel-18 | 95 | RP-233234 |
| 1030 | 488 | Study on NR frequency range 2 (FR2) Over-the-Air (OTA) testing enhancements |  | 457d | 2022-03-15 A | 2023-12-12 A | 100% |  |  | finish no earlier than 2023-12-12 | R4 | 3656h | 3656h | FS_NR_FR2_OTA_enh | 48 | Rel-18 | 95 | RP-233170 |
| 1031 | 489 | Study on NR base station (BS) RF requirement evolution |  | 321d | 2022-03-15 A | 2023-06-06 A | 100% |  |  | finish no earlier than 2023-06-06 | R4 | 2568h | 2568h | FS_NR_BS_RF_evo | 48 | Rel-18 | 95 | RP-230469 |
| 1032 | 490 | Study on enhancement for 700/800/900MHz band combinations for NR |  | 262d | 2022-03-03 A | 2023-03-03 A | 100% |  |  | start no earlier than 2022-03-03 | R4 | 2096h | 2096h | FS_NR_700800900_combo_enh | 48 | Rel-18 | 95 | RP-230388 |
| 1033 | 491 | Study on enhanced test methods for FR2 NR UEs |  | 720d | 2019-09-19 A | 2022-06-22 A | 100% |  |  | finish no earlier than 2022-06-22 | R4 | 5760h | 5760h | FS_FR2_enhTestMethods | 43 | Rel-18 | 85 | RP-221575 |
| 1034 | 492 | Study on efficient utilization of licensed spectrum that is not aligned with existing NR channel bandwidths |  | 643d | 2020-09-17 A | 2023-03-03 A | 100% |  |  | finish no earlier than 2023-03-03 | R4 | 5144h | 5144h | FS_NR_eff_BW_util | 45 | Rel-18 | 89 | RP-230579 |
| 1035 | 493 | Rel-18 Network automation | milestone | 0d? | 2016-03-15 A | 2016-03-15 A | 100% |  |  | start no earlier than 2016-03-15 |  |  |  |  |  | Rel-18 |  |  |
| 1036 | 494 | **Enablers for Network Automation for 5G phase 3** |  | 577d | 2021-12-20 A | 2024-03-03 | 99% | 2.3d | 523d |  |  | 10264h | 8340h | eNA_Ph3 | 50 | Rel-18 | 99 |  |
| 1037 | 494.1 | Study on Enablers for Network Automation for 5G - phase 3 |  | 256d | 2021-12-20 A | 2022-12-12 A | 100% |  |  | finish no earlier than 2022-12-12 | S2 | 2048h | 2048h | FS_eNA_Ph3 | 48 | Rel-18 | 94 |  |
| 1038 | 494.2 | Study on security aspects of enablers for Network Automation for 5G - phase 3 |  | 257d | 2022-03-10 A | 2023-03-03 A | 100% |  |  | finish no earlier than 2023-03-03 | S3 | 2056h | 2056h | FS_eNA_SEC_Ph3 | 48 | Rel-18 | 95 |  |
| 1039 | 494.3 | Security aspects of enablers for Network Automation for 5G - phase 3 |  | 128d | 2023-03-16 A | 2023-09-09 A | 100% |  |  | finish no earlier than 2023-09-09 | S3 | 1024h | 1024h | eNA_Ph3_SEC | 50 | Rel-18 | 99 |  |
| 1040 | 494.4 | (stage 2 of eNA_Ph3) Enablers for Network Automation for 5G phase 3 |  | 128d | 2022-12-09 A | 2023-06-06 A | 100% |  |  | finish no earlier than 2023-06-06 | S2 | 1024h | 1024h | eNA_Ph3 | 50 | Rel-18 | 98 |  |
| 1041 | 494.5 | CT3 aspects of eNA_Ph3 |  | 257d | 2023-03-13 A | 2024-03-03 | 98% | 5.14d | 523d | finish no earlier than 2024-03-03 | C3 | 2056h | 132h | eNA_Ph3 | 50 | Rel-18 | 99 |  |
| 1042 | 494.6 | CT4 aspects of eNA_Ph3 |  | 257d | 2023-03-13 A | 2024-03-03 A | 100% |  |  | finish no earlier than 2024-03-03 | C4 | 2056h | 2056h | eNA_Ph3 | 50 | Rel-18 | 99 |  |
| 1043 | 495 | Enhancement of Network Automation Enablers |  | 319d | 2022-12-15 A | 2024-03-03 A | 100% |  |  | finish no earlier than 2024-03-03 | C3 | 2552h | 2552h | eNetAE | 49 | Rel-18 | 96 |  |
| 1044 | 496 | Rel-18 other Studies | milestone | 0d? | 2016-03-15 A | 2016-03-15 A | 100% |  |  | start no earlier than 2016-03-15 |  |  |  |  |  | Rel-18 |  |  |
| 1045 | 497 | Guidelines for Extra-territorial 5G Systems |  | 526d | 2019-12-06 A | 2021-12-10 A | 100% |  |  | finish no earlier than 2021-12-12 | S1 | 4208h | 4208h | FS_5GET | 44 | Rel-18 | 86 |  |
| 1046 | 498 | Study on NRF API enhancements to avoid signalling and storing of redundant data |  | 333d | 2022-06-02 A | 2023-09-09 A | 100% |  |  | finish no earlier than 2023-09-09 | C4 | 2664h | 2664h | FS_NRFe | 49 | Rel-18 | 96 |  |
| 1047 | 499 | Rel-18 Management-only Features | milestone | 0d? | 2016-03-15 A | 2016-03-15 A | 100% |  |  | start no earlier than 2016-03-15 |  |  |  |  |  | Rel-18 |  |  |
| 1048 | 500 | Management of cloud-native Virtualized Network Functions |  | 178d | 2023-06-30 A | 2024-03-03 A | 100% |  |  | finish no earlier than 2024-03-03 | S5 | 1424h | 1424h | MCVNF | 51 | Rel-18 | 100 |  |
| 1049 | 501 | Charging enhancement for Network Slice based wholesale in roaming |  | 27d | 2023-05-01 A | 2023-06-06 A | 100% |  |  | start no earlier than 2023-05-01 | S5 | 216h | 216h | CHNSWO | 51 | Rel-18 | 100 |  |
| 1050 | 502 | Network and Service Operations for Energy Utilities |  | 194d | 2023-06-08 A | 2024-03-03 A | 100% |  |  | finish no earlier than 2024-03-03 | S5 | 1552h | 1552h | NSOEU | 51 | Rel-18 | 100 |  |
| 1051 | 503 | Study on CHF Segmentation |  | 322d | 2022-12-12 A | 2024-03-03 A | 100% |  |  | finish no earlier than 2024-03-03 | S5 | 2576h | 2576h | FS_CHFSeg | 50 | Rel-18 | 98 |  |
| 1052 | 504 | Management of Trace/MDT phase 2 |  | 322d | 2022-12-12 A | 2024-03-03 A | 100% |  |  | finish no earlier than 2024-03-03 | S5 | 2576h | 2576h | 5GMDT_Ph2 | 50 | Rel-18 | 98 |  |
| 1053 | 505 | Enhancements of EE for 5G Phase 2 |  | 525d | 2021-12-10 A | 2023-12-12 A | 100% |  |  | finish no earlier than 2023-12-12 | S5 | 4200h | 4200h | EE5GPLUS_Ph2 | 48 | Rel-18 | 94 |  |
| 1054 | 506 | Security Assurance Specification for Management Function (MnF) |  | 262d | 2021-12-10 A | 2022-12-09 A | 100% |  |  | finish no earlier than 2022-12-12 | S3 | 2096h | 2096h | SCAS_5G_MF | 48 | Rel-18 | 94 |  |
| 1055 | 507 | Multimedia Messaging Service Charging using service-based interface |  | 138d | 2022-06-02 A | 2022-12-12 A | 100% |  |  | finish no earlier than 2022-12-12 | S5 | 1104h | 1104h | MMS_CH_SBI | 49 | Rel-18 | 96 |  |
| 1056 | 508 | 5G performance measurements and KPIs phase 3 |  | 459d | 2022-06-02 A | 2024-03-03 A | 100% |  |  | finish no earlier than 2024-03-03 | S5 | 3672h | 3672h | PM_KPI_5G_Ph3 | 49 | Rel-18 | 96 |  |
| 1057 | 509 | Enhancement of QoE Measurement Collection |  | 972d | 2020-03-25 A | 2023-12-12 A | 100% |  |  | finish no earlier than 2023-12-12 | S5 | 7776h | 7776h | eQoE | 44 | Rel-18 | 87 |  |
| 1058 | 510 | Enhanced Edge Computing Management |  | 519d | 2022-03-10 A | 2024-03-03 A | 100% |  |  | finish no earlier than 2024-03-03 | S5 | 4152h | 4152h | eECM | 48 | Rel-18 | 95 |  |
| 1059 | 511 | Study on access control for management service |  | 256d | 2020-09-16 A | 2021-09-08 A | 100% |  |  | finish no earlier than 2021-09-08 | S5 | 2048h | 2048h | FS_MNSAC | 45 | Rel-17 | 89 |  |
| 1060 | 512 | Access control for management service |  | 649d | 2021-09-10 A | 2024-03-03 A | 100% |  |  | finish no earlier than 2024-03-03 | S5 | 5192h | 5192h | MSAC | 47 | Rel-18 | 93 |  |
| 1061 | 513 | Network slice provisioning enhancement |  | 590d | 2021-09-10 A | 2023-12-12 A | 100% |  |  | finish no earlier than 2023-12-12 | S5 | 4720h | 4720h | eNETSLICE_PRO | 48 | Rel-18 | 94 |  |
| 1062 | 514 | Study on YANG PUSH |  | 388d | 2020-09-16 A | 2022-03-10 A | 100% |  |  | finish no earlier than 2022-03-12 | S5 | 3104h | 3104h | FS_YANG | 45 | Rel-18 | 89 |  |
| 1063 | 515 | Study on Continuous integration continuous delivery support for 3GPP NFs. |  | 257d | 2021-03-18 A | 2022-03-11 A | 100% |  |  | finish no earlier than 2022-03-12 | S5 | 2056h | 2056h | FS_CICDNS | 46 | Rel-18 | 91 |  |
| 1064 | 516 | Study on Enhancement of service-based management architecture |  | 580d | 2021-03-18 A | 2023-06-06 A | 100% |  |  | finish no earlier than 2023-06-06 | S5 | 4640h | 4640h | FS_eSBMA | 46 | Rel-18 | 91 |  |
| 1065 | 517 | Service based management architecture |  | 254d | 2023-03-16 A | 2024-03-03 A | 100% |  |  | finish no earlier than 2024-03-03 | S5 | 2032h | 2032h | eSBMA | 50 | Rel-18 | 99 |  |
| 1066 | 518 | Study on Enhancement of the management aspects related to NWDAF |  | 387d | 2021-12-13 A | 2023-06-06 A | 100% |  |  | finish no earlier than 2023-06-06 | S5 | 3096h | 3096h | FS_MANWDAF | 48 | Rel-18 | 94 |  |
| 1067 | 519 | Management Aspects related to NWDAF |  | 195d | 2023-03-16 A | 2023-12-12 A | 100% |  |  | finish no earlier than 2023-12-12 | S5 | 1560h | 1560h | MANWDAF | 50 | Rel-18 | 99 |  |
| 1068 | 520 | Study on enhancement of management of non-public networks |  | 320d | 2021-12-13 A | 2023-03-03 A | 100% |  |  | finish no earlier than 2023-03-03 | S5 | 2560h | 2560h | FS_OAM_eNPN | 48 | Rel-18 | 94 |  |
| 1069 | 521 | Study on new aspects of EE for 5G networks Phase 2 |  | 387d | 2021-12-13 A | 2023-06-06 A | 100% |  |  | finish no earlier than 2023-06-06 | S5 | 3096h | 3096h | FS_EE5G_Ph2 | 48 | Rel-18 | 94 |  |
| 1070 | 522 | Study on Deterministic Communication Service Assurance |  | 582d | 2021-12-13 A | 2024-03-03 A | 100% |  |  | finish no earlier than 2024-03-03 | S5 | 4656h | 4656h | FS_DCSA | 48 | Rel-18 | 94 |  |
| 1071 | 523 | Study on evaluation of autonomous network levels |  | 582d | 2021-12-13 A | 2024-03-03 A | 100% |  |  | finish no earlier than 2024-03-03 | S5 | 4656h | 4656h | FS_ANLEVA | 48 | Rel-18 | 94 |  |
| 1072 | 524 | Study on enhancement of autonomous network levels |  | 523d | 2021-12-13 A | 2023-12-12 A | 100% |  |  | finish no earlier than 2023-12-12 | S5 | 4184h | 4184h | FS_eANL | 48 | Rel-18 | 94 |  |
| 1073 | 525 | Study on enhanced intent driven management services for mobile networks |  | 387d | 2021-12-13 A | 2023-06-06 A | 100% |  |  | finish no earlier than 2023-06-06 | S5 | 3096h | 3096h | FS_eIDMS_MN | 48 | Rel-18 | 94 |  |
| 1074 | 526 | Study on Basic SBMA enabler enhancements |  | 324d | 2022-03-10 A | 2023-06-06 A | 100% |  |  | finish no earlier than 2023-06-06 | S5 | 2592h | 2592h | FS_eSBMAe | 48 | Rel-18 | 95 |  |
| 1075 | 527 | Study on alignment with ETSI MEC for Edge computing management |  | 324d | 2022-03-10 A | 2023-06-06 A | 100% |  |  | finish no earlier than 2023-06-06 | S5 | 2592h | 2592h | FS_MEC_ECM | 48 | Rel-18 | 95 |  |
| 1076 | 528 | Study on Management Aspect of 5GLAN |  | 257d | 2022-03-10 A | 2023-03-03 A | 100% |  |  | finish no earlier than 2023-03-03 | S5 | 2056h | 2056h | FS_5GLAN_Mgt | 48 | Rel-18 | 95 |  |
| 1077 | 529 | Management Aspect of 5GLAN |  | 195d | 2023-03-16 A | 2023-12-12 A | 100% |  |  | finish no earlier than 2023-12-12 | S5 | 1560h | 1560h | 5GLAN_Mgt | 50 | Rel-18 | 99 |  |
| 1078 | 530 | Study on Management of Cloud Native Virtualized Network Functions |  | 324d | 2022-03-10 A | 2023-06-06 A | 100% |  |  | finish no earlier than 2023-06-06 | S5 | 2592h | 2592h | FS_MCVNF | 48 | Rel-18 | 95 |  |
| 1079 | 531 | Study on Management Aspects of 5G MOCN Network Sharing Phase2 |  | 324d | 2022-03-10 A | 2023-06-06 A | 100% |  |  | finish no earlier than 2023-06-06 | S5 | 2592h | 2592h | FS_MANS_ph2 | 48 | Rel-18 | 95 |  |
| 1080 | 532 | Management Aspects of 5G Network Sharing Phase2 |  | 194d | 2023-06-08 A | 2024-03-03 A | 100% |  |  | finish no earlier than 2024-03-03 | S5 | 1552h | 1552h | MANS_ph2 | 51 | Rel-18 | 100 |  |
| 1081 | 533 | Study on Management of Trace/MDT phase 2 |  | 324d | 2022-03-10 A | 2023-06-06 A | 100% |  |  | finish no earlier than 2023-06-06 | S5 | 2592h | 2592h | FS_5GMDT_Ph2 | 48 | Rel-18 | 95 |  |
| 1082 | 534 | Study on Fault Supervision Evolution |  | 519d | 2022-03-10 A | 2024-03-03 A | 100% |  |  | finish no earlier than 2024-03-03 | S5 | 4152h | 4152h | FS_FSEV | 48 | Rel-18 | 95 |  |
| 1083 | 535 | Study on measurement data collection to support RAN intelligence |  | 138d | 2022-06-02 A | 2022-12-12 A | 100% |  |  | finish no earlier than 2022-12-12 | S5 | 1104h | 1104h | FS_MEDACO_RAN | 49 | Rel-18 | 96 |  |
| 1084 | 536 | Study on Nchf charging services phase 2 |  | 654d | 2021-06-11 A | 2023-12-12 A | 100% |  |  | finish no earlier than 2023-12-12 | S5 | 5232h | 5232h | FS_NCHF_Ph2 | 47 | Rel-18 | 92 |  |
| 1085 | 537 | CHF Distributed Availability |  | 128d | 2023-03-16 A | 2023-09-09 A | 100% |  |  | finish no earlier than 2023-09-09 | S5 | 1024h | 1024h | DIST_CH | 50 | Rel-18 | 99 |  |
| 1086 | 538 | Study on 5G roaming charging architecture for wholesale and retail scenarios |  | 587d | 2021-06-11 A | 2023-09-09 A | 100% |  |  | finish no earlier than 2023-09-09 | S5 | 4696h | 4696h | FS_CHROAM | 47 | Rel-18 | 92 |  |
| 1087 | 539 | Charging for roaming and additional actor using CHF to CHF interface |  | 130d | 2023-09-06 A | 2024-03-03 A | 100% |  |  | finish no earlier than 2024-03-03 | S5 | 1040h | 1040h | CHRACHF | 51 | Rel-18 | 101 |  |
| 1088 | 540 | Methodology for deprecation |  | 130d | 2022-09-12 A | 2023-03-10 A | 100% |  |  | finish no earlier than 2023-03-12 | S5 | 1040h | 1040h | OAM_MetDep | 49 | Rel-18 | 97 |  |
| 1089 | 541 | Study on Data management phase 2 |  | 387d | 2022-09-12 A | 2024-03-03 A | 100% |  |  | finish no earlier than 2024-03-03 | S5 | 3096h | 3096h | FS_MADCOL_ph2 | 49 | Rel-18 | 97 |  |
| 1090 | 542 | Study on Time Sensitive Networking (TSN) Charging |  | 328d | 2022-09-12 A | 2023-12-12 A | 100% |  |  | finish no earlier than 2023-12-12 | S5 | 2624h | 2624h | FS_TSNCH | 49 | Rel-18 | 97 |  |
| 1091 | 543 | Charging Aspects of TSN |  | 130d | 2023-09-06 A | 2024-03-03 A | 100% |  |  | finish no earlier than 2024-03-03 | S5 | 1040h | 1040h | TSN_CH | 51 | Rel-18 | 101 |  |

Notes:
- 1022: WI rapporteur name: T-Mobile USA
- 1023: ; 7/6/23: CD:06/06/2023->12/12/2023 / WI rapporteur name: T-Mobile USA
- 1024: ; 7/6/23: CD:09/09/2023->12/12/2023 / WI rapporteur name: T-Mobile USA
- 1025: -
- 1026: ; 7/6/23: Compl:0%->86%; 7/6/23: CD:06/06/2023->09/09/2023; 6/9/23: FCD:09/09/2023->12/12/2023; Compl:86%->80%; WID: RP-230789->RP-231141; Stat Rep: ->RP-232378; Rapporteur: Huawei->Zhang, Peng, Huawei; Rap eMail: ->zhangpeng169@huawei.com; ; 21/9/23: FCD:12/12/2023->08/09/2023; Compl:80%->100%; Stat Rep: RP-232378->RP-232661; / WI rapporteur name: Zhang, Peng, Huawei / WI rapporteur e-mail: zhangpeng169@huawei.com
- 1027: 29/6/23: 0%->20; 21/9/23: Compl:20%->40%; WID: RP-230736->RP-231945; Stat Rep: RP-231291->RP-231944; Rapporteur: Asbjörn Grövlen, Ericsson->Asbj rn Gr vlen, Ericsson; ; 21/9/23: 37.911 added;; 2/1/24: 40%->100 / Impacted TSs and TRs: 37.911 / WI rapporteur name: Asbj rn Gr vlen, Ericsson / WI rapporteur e-mail: asbjorn.grovlen@ericsson.com
- 1028: 9/1/23: WID:RP-222685->RP-223396; 17/3/23: 38.848 added;; 31/3/23: Compl:0%->50%; WID: RP-223396->RP-222685; Stat Rep: ->RP-230669; Rapporteur: Huawei->Matthew Webb, Huawei; Rap eMail: ->matthew.webb@huawei.com; ; 29/6/23: 50%->60; 29/6/23: FCD:06/06/...; 6/10/23: 100%->100 / Impacted TSs and TRs: 38.848 / WI rapporteur name: Matthew Webb, Huawei / WI rapporteur e-mail: matthew.webb@huawei.com
- 1029: TR 37.8xx; LTE only combos will not be considered ; 20/6/22: FCD:15/06/2023->23/06/2022; Stat Rep: ->RP-221266 / 1769; Rapporteur: ZTE->Zhifeng Ma, ZTE Corporation; Rap eMail: ->ma.zhifeng@zte.com.cn12/7/22: WID:RP-220956->RP-221790; 13/7/22: FCD:...;...; 8/12/23: Compl:95%->100%; Stat Rep: RP-231862->RP-233234; / Impacted TSs and TRs: 38.846 / WI rapporteur name: Zhifeng Ma, ZTE Corporation / WI rapporteur e-mail: ma.zhifeng@zte.com.cn
- 1030: compare REL-16 SI FS_NR_test_methods and REL-17 SI FS_FR2_enhTestMethods; TR 38.3xx ; 6/6/22: CD:15/12/2023->23/12/2022; 6/6/22: Stat Rep: ->RP-221391; 20/6/22: Rapporteur: Qualcomm->Bin Han, Qualcomm Incorporated; Rap eMail: ->binhan@qti.qualcomm.com...; 2/1/24: WID:RP-230814->RP-233171 / Impacted TSs and TRs: 38.871 / WI rapporteur name: Bin Han, Qualcomm Incorporated / WI rapporteur e-mail: binhan@qti.qualcomm.com
- 1031: for NR FR2 mmWave BSs; TR 38.8xx 6/6/22: CD:15/06/2023->23/06/20226/6/22: Stat Rep: ->RP-221530; 20/6/22: Rapporteur: Huawei->Richard Kybett, Huawei; Rap eMail: ->Richard.kybett@huawei.com13/7/22: FCD:23/06/2022->06/20; 13/7/22: 38.877 added;;...; 23/...; ; ; ; ; ; ; ; ; ; ; ; ; ; ; ; ; ; ; ; ; ; ; 7/6/23: Compl:80%->100% / Impacted TSs and TRs: 38.877 / WI rapporteur name: Liehai Liu, Huawei / WI rapporteur e-mail: liuliehai@huawei.com
- 1032: TR 38.8xx ; 6/6/22: CD:08/06/2021->23/03/2023; 6/6/22: Stat Rep: ->RP-221460; 20/6/22: Rapporteur: CATT->Yuexia Song, CATT; Rap eMail: ->songyuexia@catt.cn12/7/22: WID:RP-221016->RP-221464; 13/7/22: 38.872 added ; ;...; 23/9/22: WID:RP-221464->RP-2225...; 17/3/23: FCD:28/02/2023->03/03/2023; Compl:80%->100%; Stat Rep: RP-223145->RP-230388; / Impacted TSs and TRs: 38.872 / WI rapporteur name: Huiping Shan, CATT / WI rapporteur e-mail: shanhuiping@catt.cn
- 1033: TR 38.8XX; 14/1/20: WID:RP-192322->RP-192430; 28/7/20: WID:RP-192430->RP-201110; 25/9/20: WID:RP-201110->RP-201862; 7/4/21: WID:RP-201862->RP-210633; 2/7/21: WID:RP-210633->RP-211600; ; 04/22: Rel-17->Rel-18 ; ; 20/6/22: Rapporteur: Apple->Anatoliy ...; 12/7/22: WID:RP-211600->RP-221574 / WI rapporteur name: Anatoliy IOFFE, Ruixin WANG, Aida Vera LOPEZ, Apple Inc., vivo, Intel Corporation / WI rapporteur e-mail: aioffe@apple.com, ruixin.wang@vivo.com, aida.l.vera.lopez@intel.com
- 1034: TR 38.8xx ; 6/1/21: WID:RP-202103->RP-202339; 7/4/21: WID:RP-202339->RP-210706; 2/7/21: WID:RP-210706->RP-211468; 13/9/21: Compl:0%->50%; ; 6/1/22: WID:RP_211468->RP-213657 ; 5/4/22: WID:RP-213657->RP-220461; 04/22: Rel-17->Rel-18; ; 20/6/22: Rappor...; 17/3/23: FCD:28/02/2023->03/03/2023; Compl:85%->100%; Stat Rep: RP- 223273->RP-230579; / Impacted TSs and TRs: 38.844 / WI rapporteur name: Esther Sienkiewicz, Ericsson / WI rapporteur e-mail: esther dot sienkiewicz at ericsson dot com
- 1035: -
- 1036: 10/12/22: 0%->25 / Impacted TSs and TRs: 23.501; 23.502; 23.503; 23.288 / WI rapporteur name: Aihua Li, China Mobile / WI rapporteur e-mail: liaihua@chinamobile
- 1037: 21/1/22: 23.700-81 added;; 21/1/22: 23.700-85 added;; 12/3/22: 0%->13; 4/6/22: 13%->50; 21/6/22: WID:SP-211650->SP-220678; 12/9/22: 50%->75; 12/9/22: FCD:12/09/2022->12/22; 10/12/22: 75%->100 / Impacted TSs and TRs: 23.700-81; 23.700-85 / WI rapporteur name: Aihua Li, China Mobile / WI rapporteur e-mail: liaihua@chinamobile.com
- 1038: 4/6/22: 0%->10; 13/7/22: 33.738 added;; 12/9/22: 10%->35; 11/12/22: 35%->60; 17/3/23: 60%->80; 8/6/23: 80%->95; 15/3/24: 95%->100 / Impacted TSs and TRs: 33.738 / WI rapporteur name: Chang Liu, China Mobile / WI rapporteur e-mail: liuchangyjy@chinamobile.com
- 1039: ; 8/6/23: 0%->65; 15/3/24: 65%->100 / Impacted TSs and TRs: 33.501 / WI rapporteur name: Chang Liu, China Mobile / WI rapporteur e-mail: liuchangyjy@chinamobile.com
- 1040: 10/12/22: 0%->25; 15/3/23: 13%->65; 15/3/23: WID:SP-221345->SP-230110; 8/6/23: 65%->100 / Impacted TSs and TRs: 23.501; 23.502; 23.503; 23.288 / WI rapporteur name: Aihua Li, China Mobile / WI rapporteur e-mail: liaihua@chinamobile
- 1041: ; 6/6/23: Compl:15%->65% / Impacted TSs and TRs: 29.507.29.508.29.122.29.513.29.517.29.519.29.520.29.522.29.523.29.525.29.551.29.552.29.574.29.575.29.576.29.591.29.503.29.504.29.505.29.510.29.515.29.518.29.564.29.571 / WI rapporteur name: Zhennning Huang, China Mobile / WI rapporteur e-mail: huangzhenning@chinamobile.com
- 1042: ; 6/6/23: Compl:5%->30% / Impacted TSs and TRs: 29.507.29.508.29.122.29.513.29.517.29.519.29.520.29.522.29.523.29.525.29.551.29.552.29.574.29.575.29.576.29.591.29.503.29.504.29.505.29.510.29.515.29.518.29.564.29.571 / WI rapporteur name: Zhennning Huang, China Mobile / WI rapporteur e-mail: huangzhenning@chinamobile.com
- 1043: ; 6/6/23: Compl:70%->90%; 6/6/23: CD:12/12/2023->03/03/2024; ;... / Impacted TSs and TRs: 29.517; 29.520; 29.522; 29.552; 29.574; 29.575; 29.576; 29.591 / WI rapporteur name: Xuefei Zhang, Huawei / WI rapporteur e-mail: summer.xuefei@huawei.com
- 1044: -
- 1045: 12/9/20: 0%->20; 5/12/20: 20%->40; 19/3/21: FCD:11/09/2020->12/21; 19/3/21: 40%->50; 11/6/21: 50%->60; 13/9/21: 60%->80; 10/12/21: 80%->100 / WI rapporteur name: Cyril MICHEL,Thales / WI rapporteur e-mail: cyril.michel@thalesaleniaspace.com
- 1046: 13/7/22: 29.831 added;; 6/6/23: Compl:50%->60%; 30/6/23: WID:CP-221088->CP-231022 / Impacted TSs and TRs: 29.xxx; 29.831 / WI rapporteur name: Wiehe, Ulrich, Nokia / WI rapporteur e-mail: Ulrich.wiehe@nokia.com
- 1047: -
- 1048: ; 7/9/23: 0%->30; 8/12/23: 30%->95; 14/3/24: 95%->100 / Impacted TSs and TRs: 28.531; 28.533; 28.526 / WI rapporteur name: China Mobile Guangjing Cao / WI rapporteur e-mail: caoguangjing@chinamobile.com
- 1049: ; 8/12/23: 0%->100 / Impacted TSs and TRs: 32.240; 32.255; 32.256; 32.291; 32.298 / WI rapporteur name: Maryse Gardella, MATRIXX Software, / WI rapporteur e-mail: Maryse dot Gardella at Matrixx dot com
- 1050: ; 30/6/23: 28.318 added;; 7/9/23: 0%->30; 8/12/23: 30%->60; 4/1/24: 28.879 added;; 14/3/24: 60%->100 / Impacted TSs and TRs: 28.552; 28.554; 28.622 ; 28.318; 28.879 / WI rapporteur name: Erik Guttman , Samsung; / WI rapporteur e-mail: <erik.guttman@samsung.com
- 1051: 17/3/23: 0%->5; 17/3/23: 28.840 added;; 8/6/23: 5%->12; 7/9/23: 12%->18; 8/12/23: 18%->55; 8/12/23: FCD:09/09/2023->/2024; 14/3/24: 55%->100 / Impacted TSs and TRs: 28.840 / WI rapporteur name: João Rodrigues, Nokia / WI rapporteur e-mail: joao.a.rodrigues@nokia.com
- 1052: ; 8/6/23: 0%->; 30/6/23: WID:SP-221163->SP-230777; 7/9/23: 0%->40; 7/9/23: FCD:12/12/2023->/24; 8/12/23: 40%->90; 14/3/24: 90%->100 / Impacted TSs and TRs: 28.621; 28.622; 28.623; 32.421; 32.422; 32.423 / WI rapporteur name: Swaminathan, Sivaramakrishnan, Nokia / WI rapporteur e-mail: sivaramakrishnan<dot>swaminathan<at>nokia<dot>com
- 1053: ; 12/9/22: 0%->10; 12/9/22: FCD:10/03/2023->06/23; 11/12/22: 10%->25; 17/3/23: 25%->30; 17/3/23: FCD:06/06/2023->12/23; 8/6/23: 30%->35; 7/9/23: 35%->55; 8/12/23: 55%->100 / Impacted TSs and TRs: 28.310; 28.552; 28.554; 28.541 / WI rapporteur name: Cornily Jean-Michel, Huawei / WI rapporteur e-mail: jean.michel.cornily@huawei.com
- 1054: ; 7/1/22: 33.526 added;; 12/3/22: 0%->10; 4/6/22: 10%->30; 12/9/22: 30%->60; 11/12/22: 60%->75; 17/3/23: 75%->85; 8/6/23: 85%->95; 7/9/23: 95%->100 / Impacted TSs and TRs: 33.926 ; 33.526 / WI rapporteur name: Noamen Ben Henda, Huawei Technologies Co., Ltd. / WI rapporteur e-mail: noamen.ben.henda@huawei.com
- 1055: ; 17/8/22: WID:SP-220486->SP-220689; 12/9/22: 0%->25; 12/9/22: FCD:12/09/2022->12/22; 11/12/22: 25%->100 / Impacted TSs and TRs: 32.240; 32.270; 32.290; 32.291; 32.298 / WI rapporteur name: Törnkvist, Robert, Ericsson AB / WI rapporteur e-mail: robert(dot)tornkvist(at)Ericson(dot)com
- 1056: ; 17/8/22: WID:SP-220489->SP-220690; 12/9/22: 0%->15; 11/12/22: 15%->50; 17/3/23: 50%->60; 8/6/23: 60%->70; 8/6/23: 70%->; 7/9/23: 70%->80; 8/12/23: 80%->99; 8/12/23: FCD:12/12/2023->/2024; 3/1/24: WID:SP-220690->SP-231710; 4/1/24: 28.558 added;; 14/3...; 2/4/24: WID:SP-231710->SP-240271 / Impacted TSs and TRs: 28.552; 32.425; 28.554; 28.550 ; 28.558 / WI rapporteur name: Chen, Xiumin, China Telecom / WI rapporteur e-mail: (chenxiumin<at>chinatelecom<dot>cn)
- 1057: ; 5/12/20: 0%->5; 21/3/21: 5%->15; 11/6/21: 15%->20; 13/9/21: 20%->40; 13/9/21: FCD:Thu 16/09/->03/22; 13/12/21: 40%->60; 12/3/22: 60%->90; 4/6/22: 90%->95; 4/6/22: FCD:11/03/2022->12/22; Rel-17->Rel-18; 12/9/22: 95%->70; 12/9/22: FCD:12/12/2022->12/2...; 8/6/23: 100%-> / Impacted TSs and TRs: 28.307; 28.308; 28.309; 28.404; 28.405; 28.406; 28.622; 28.623; 28.533 / WI rapporteur name: Bagher Zadeh, Ericsson / WI rapporteur e-mail: Bagher Zadeh <at>ericsson<dot>ericsson
- 1058: ; 4/6/22: 0%->10; 12/9/22: 10%->35; 11/12/22: 35%->50; 17/3/23: 50%->50; 17/3/23: FCD:03/03/2023->12/23; 17/3/23: FCD:12/12/2023->/23; 17/3/23: 50%->100; 30/6/23: WID:SP-220154->SP-230775; 8/12/23: 100%->70; 8/12/23: FCD:03/03/2023->/2024; 14/3/24: 70%->100 / Impacted TSs and TRs: 28.541; 28.538; 28.552; 28.554; 28.531; 28.532 / WI rapporteur name: Deepanshu Gautam, Samsung / WI rapporteur e-mail: deepanshu<dot>g<at>samsung<dot>com
- 1059: 25/9/20: WID:SP-200764->SP-200853; 5/12/20: 0%->5; 21/3/21: 5%->35; 21/3/21: FCD:12/03/2021->09/21; 11/6/21: 35%->80; 11/6/21: FCD:Wed 08/09/->09/21; 13/9/21: 80%->100 / WI rapporteur name: Jing Ping, Nokia / WI rapporteur e-mail: jing.ping@nokia-sbell.com
- 1060: ; 12/3/22: 0%->60; 4/6/22: 60%->67; 4/6/22: FCD:10/12/2021->12/22; Rel-17->Rel-18; 11/12/22: 67%->68; 11/12/22: FCD:12/12/2022->12/23; 17/3/23: 68%->69; 8/6/23: 69%->72; 7/9/23: 72%->73; 8/12/23: 73%->75; 8/12/23: FCD:12/12/2023->/2024; 3/1/24: WID:SP...; 14/3/24: 75%->100 / Impacted TSs and TRs: 28.319 / WI rapporteur name: Clifton Fernandes, Nokia / WI rapporteur e-mail: Clifton.fernandes@nokia.com
- 1061: ; 12/3/22: 0%->50; 4/6/22: 50%->85; 4/6/22: FCD:11/03/2022->09/22; Rel=-17->Rel-18; 12/9/22: 85%->85; 12/9/22: FCD:12/09/2022->12/12/22; 11/12/22: 85%->90; 11/12/22: FCD:12/12/2022->/23; 17/3/23: 90%->90; 17/3/23: FCD:03/03/2023->12/23; 7/9/23: 90%->100 / Impacted TSs and TRs: 28.531; 28.541 / WI rapporteur name: Deepanshu Gautam , Samsung / WI rapporteur e-mail: deepanshu<dot>g<at>samsung<dot>com
- 1062: 5/12/20: 0%->5; 21/3/21: 5%->10; 21/3/21: FCD:12/03/2021->09/21; 11/6/21: 10%->10; 13/9/21: FCD:Wed 08/09/->12/21; 13/12/21: FCD:Fri 10/12/->03/22; 12/3/22: Rel-17->Rel-18; 8/12/23: 10%->100 / WI rapporteur name: Lengyel, Balazs, Ericsson / WI rapporteur e-mail: balazs.lengyel@ericsson.com
- 1063: ; 11/6/21: 0%->15; 13/9/21: 15%->30; 13/9/21: FCD:Fri 10/09/->12/21; 13/12/21: 30%->75; 13/12/21: FCD:Fri 10/12/->03/22; 7/1/22: 28.901 added;12/3/22: Rel-17->Rel-18; 4/6/22: 75%->100 / Impacted TSs and TRs: New ; 28.901 / WI rapporteur name: Vaishnavi, Ishan, Lenovo / WI rapporteur e-mail: ivaishnavi@lenovo.com
- 1064: ; 11/6/21: 0%->10; 13/9/21: 10%->15; 13/12/21: 15%->45; 13/12/21: FCD:Fri 10/12/->03/22; 12/3/22: Rel-17->Rel-18; 4/6/22: 45%->60; 12/9/22: 60%->75; 12/9/22: FCD:11/03/2022->03/23; 11/12/22: 75%->80; 17/3/23: 80%->85; 17/3/23: FCD:03/03/2023->/23; 8/6/23: 85%->100 / Impacted TSs and TRs: New / WI rapporteur name: Lan Zou, Huawei / WI rapporteur e-mail: zoulan@huawei.com
- 1065: ; 31/3/23: 28.111 added;; 30/6/23: WID:SP-230174->SP-230776; 7/9/23: 0%->10; 21/9/23: 32.161 added;; 8/12/23: 10%->55; 8/12/23: FCD:12/12/2023->/2024; 3/1/24: WID:SP-230776->SP-231443; 4/1/24: 28.871 added;; 14/3/24: 55%->100 / Impacted TSs and TRs: 32.404; 28.622; 28.623; 32.300; 28.532; 28.545; 28.532; 28.532; 28.532; 28.158; 28.532 ; 28.111; 32.161; 28.871 / WI rapporteur name: Zhang Kai, Huawei / WI rapporteur e-mail: kai.zhangkai@huawei.com
- 1066: 7/1/22: 28.864 added;; 4/6/22: 0%->30; 12/9/22: 30%->65; 11/12/22: 65%->75; 11/12/22: FCD:12/12/2022->/23; 8/6/23: 75%->; 8/6/23: FCD:03/03/2023->/23; 8/6/23: 75%->100 / Impacted TSs and TRs: 28.864 / WI rapporteur name: ZHAO, Song, China Telecom / WI rapporteur e-mail: zhaosong1@chinatelecom.cn
- 1067: ; 8/6/23: 0%->50; 7/9/23: 50%->75; 8/12/23: 75%->100; 4/1/24: 28.877 added; / Impacted TSs and TRs: 28.541; 28.552; 28.554 ; 28.877 / WI rapporteur name: Niu, Yuxia, China Telecom / WI rapporteur e-mail: niuyx@chinatelecom.cn
- 1068: 7/1/22: 28.907 added;; 4/6/22: 0%->40; 12/9/22: 40%->80; 11/12/22: 80%->90; 11/12/22: FCD:12/12/2022->/23; 16/3/23: WID:SP-211436->SP-230185; 17/3/23: 90%->100 / Impacted TSs and TRs: 28.907 / WI rapporteur name: ZHANG, Kai, Huawei / WI rapporteur e-mail: kai.zhangkai@huawei.com
- 1069: 7/1/22: 28.913 added;; 4/6/22: 0%->10; 12/9/22: 10%->25; 11/12/22: 25%->50; 17/3/23: 50%->50; 8/6/23: 50%->100 / Impacted TSs and TRs: 28.913 / WI rapporteur name: Cornily Jean-Michel, Orange / WI rapporteur e-mail: jean.michel.cornily@huawei.com
- 1070: 7/1/22: 28.865 added;; 4/6/22: 0%->30; 12/9/22: 30%->32; 12/9/22: FCD:12/12/2023->12/22; 11/12/22: FCD:12/12/2022->/23; 17/3/23: 32%->45; 17/3/23: FCD:03/03/2023->/23; 8/6/23: 45%->60; 8/6/23: FCD:06/06/2023->/24; 7/9/23: 60%->; 8/12/23: 60%->92; 14/3/...; 2/4/24: WID:SP-211442->SP-240269 / Impacted TSs and TRs: 28.865 / WI rapporteur name: <Zhang>, <Jian>, <Huawei> / WI rapporteur e-mail: justincn.zhang@huawei.com
- 1071: 7/1/22: 28.909 added;; 4/6/22: 0%->10; 11/12/22: 10%->10; 8/6/23: 10%->60; 8/6/23: FCD:10/03/2023->12/24; 7/9/23: 60%->70; 7/9/23: FCD:12/12/2024->/24; 8/12/23: 70%->80; 14/3/24: 80%->100 / Impacted TSs and TRs: 28.909 / WI rapporteur name: Cao Xi, China Mobile / WI rapporteur e-mail: caoxi@chinamobile.com
- 1072: 7/1/22: 28.910 added;; 4/6/22: 0%->25; 12/9/22: 25%->30; 12/9/22: FCD:12/09/2022->12/22; 11/12/22: 30%->30; 11/12/22: FCD:12/12/2022->/23; 8/6/23: 30%->75; 8/6/23: FCD:03/03/2023->12/23; 7/9/23: 75%->85; 8/12/23: 85%->100 / Impacted TSs and TRs: 28.910 / WI rapporteur name: Cao Xi, China Mobile / WI rapporteur e-mail: caoxi@chinamobile.com
- 1073: 7/1/22: 28.912 added;; 4/6/22: 0%->40; 12/9/22: 40%->80; 12/9/22: FCD:12/09/2022->12/22; 11/12/22: 80%->90; 11/12/22: FCD:12/12/2022->/23; 8/6/23: 90%->; 8/6/23: FCD:03/03/2023->/23; 8/6/23: 90%->100 / Impacted TSs and TRs: 28.912 / WI rapporteur name: Xu Ruiyue, Huawei / WI rapporteur e-mail: Xuruiyue@huawei.com
- 1074: 5/4/22: 28.831 added;; 4/6/22: 0%->10; 12/9/22: 10%->25; 11/12/22: 25%->35; 11/12/22: FCD:12/12/2022->/23; 17/3/23: 35%->70; 8/6/23: 70%->100; 30/6/23: WID:SP-220145->SP-230774 / Impacted TSs and TRs: 28.831 / WI rapporteur name: Pollakowski, Olaf, Nokia / WI rapporteur e-mail: olaf.pollakowski@nokia.com
- 1075: 5/4/22: 28.903 added;; 4/6/22: 0%->15; 12/9/22: 15%->50; 12/9/22: FCD:12/09/2022->03/23; 17/3/23: 50%->70; 17/3/23: FCD:03/03/2023->/23; 8/6/23: 70%->100 / Impacted TSs and TRs: 28.903 / WI rapporteur name: Shitao Li, Huawei / WI rapporteur e-mail: lishitao<at>huawei<dot>com
- 1076: 5/4/22: 28.833 added;; 4/6/22: 0%->25; 12/9/22: 25%->65; 12/9/22: FCD:12/12/2022->03/23; 11/12/22: 65%->98; 17/3/23: 98%->100; 8/6/23: 100%-> / Impacted TSs and TRs: 28.833 / WI rapporteur name: Xiaowen Sun, CMCC / WI rapporteur e-mail: sunxiaowen@chinamobile.com
- 1077: ; 8/6/23: 0%->45; 7/9/23: 45%->90; 8/12/23: 90%->100 / Impacted TSs and TRs: 28.541; 28.552; 28.554 / WI rapporteur name: Yushuang Hu, CMCC, / WI rapporteur e-mail: huyushuang@chinamobile.com
- 1078: 5/4/22: 28.834 added;; 4/6/22: 0%->5; 12/9/22: 5%->30; 11/12/22: 30%->70; 17/3/23: 70%->95; 17/3/23: FCD:03/03/2023->/23; 8/6/23: 95%->100; 4/1/24: 28.869 added; / Impacted TSs and TRs: 28.834; 28.869 / WI rapporteur name: China Mobile Guangjing Cao / WI rapporteur e-mail: caoguangjing@chinamobile.com
- 1079: 5/4/22: 28.835 added;; 4/6/22: 0%->30; 12/9/22: 30%->75; 12/9/22: FCD:12/09/2022->03/23; 11/12/22: 75%->90; 17/3/23: 90%->94; 17/3/23: FCD:03/03/2023->/23; 8/6/23: 94%->100; 4/1/24: 28.878 added; / Impacted TSs and TRs: 28.835; 28.878 / WI rapporteur name: Zhaoning Wang, ChinaUnicom / WI rapporteur e-mail: wangzn18@chinaunicom.cn
- 1080: ; 7/9/23: 0%->30; 8/12/23: 30%->60; 14/3/24: 60%->100 / Impacted TSs and TRs: 32.130; 28.541; 28.552 / WI rapporteur name: Wang Zhaoning, China Unicom, / WI rapporteur e-mail: wangzn18@chinaunicom.cn,
- 1081: 5/4/22: 28.837 added;; 4/6/22: 0%->15; 12/9/22: 15%->25; 12/9/22: FCD:12/12/2022->03/23; 11/12/22: 25%->35; 11/12/22: FCD:10/03/2023->/23; 17/3/23: 35%->60; 8/6/23: 60%->100; 30/6/23: WID:SP-220152->SP-230773 / Impacted TSs and TRs: 28.837 / WI rapporteur name: Sivaramaskrishnan Swaminathan, Nokia / WI rapporteur e-mail: sivaramakrishnan.swaminathan@nokia.com
- 1082: 5/4/22: 28.830 added;; 4/6/22: 0%->10; 12/9/22: 10%->20; 8/6/23: 20%->; 8/6/23: 20%->30; 8/6/23: FCD:03/03/2023->/24; 7/9/23: 30%->40; 8/12/23: 40%->65; 14/3/24: 65%->100 / Impacted TSs and TRs: 28.830 / WI rapporteur name: Deng LingLi (China Mobile)
- 1083: 12/9/22: 0%->10; 11/12/22: 10%->100; 8/6/23: 100%-> / WI rapporteur name: Chou, Joey, Intel / WI rapporteur e-mail: joey<dot>chou<at>intel<dot>com
- 1084: 12/3/22: 0%->40; 4/6/22: 40%->60; 4/6/22: FCD:11/03/2022->03/23; 21/6/22: 60%->100. 13/7/22: moved Rel-17->Rel-18, as per Gerald e-mail 21/06/22, 15:03; 12/9/22: 100%->70; 11/12/22: 70%->94; 11/12/22: 94%->75; 17/3/23: 75%->98; 17/3/23: 98%->88; 8/6/23...; 8/12/23: 96%->100 / WI rapporteur name: Tornkvist, Robert, Ericsson AB / WI rapporteur e-mail: robert(dot)tornkvist(at)Ericsson(dot)com
- 1085: ; 8/12/23: 0%->100 / Impacted TSs and TRs: 32.240; 32.290 / WI rapporteur name: João Rodrigues, Nokia / WI rapporteur e-mail: joao.a.rodrigues@nokia.com
- 1086: 13/9/21: 0%->10; 12/3/22: 10%->50; 4/6/22: 50%->100; 4/6/22: FCD:11/03/2022->03/23; 4/6/22: 100%->75; 4/6/22: 0%->75; 21/6/22: 75%->100 13/7/22: moved Rel-17->Rel-18, as per Gerald e-mail 21/06/22, 15:03; 12/9/22: 100%->85; 11/12/22: 85%->90; 17/3/23: ...; 7/9/23: 99%->100 / WI rapporteur name: Tornkvist, Robert, Ericsson AB / WI rapporteur e-mail: robert(dot)tornkvist(at)Ericsson(dot)com
- 1087: ; 8/12/23: 0%->40; 14/3/24: 40%->100 / Impacted TSs and TRs: 32.240; 32.255; 32.256; 32.290; 32.291; 32.298 / WI rapporteur name: Törnkvist, Robert, Ericsson AB / WI rapporteur e-mail: robert(dot)tornkvist(at)Ericsson(dot)com
- 1088: ; 11/12/22: 0%->95; 17/3/23: 95%->100 / Impacted TSs and TRs: 32.156; 32.160 / WI rapporteur name: Lengyel, Balázs, Ericsson / WI rapporteur e-mail: balazs.lengyel@ericsson.com
- 1089: ; 23/9/22: 28.842 added;; 11/12/22: 0%->5; 11/12/22: FCD:12/06/2023->/23; 17/3/23: 5%->10; 8/6/23: 10%->25; 8/6/23: FCD:06/06/2023->/24; 7/9/23: 25%->45; 8/12/23: 45%->80; 4/1/24: 28.873 added;; 14/3/24: 80%->100 / Impacted TSs and TRs: ; 28.842; 28.873 / WI rapporteur name: Pollakowski, Olaf, Nokia / WI rapporteur e-mail: olaf.pollakowski@nokia.com
- 1090: 23/9/22: 28.839 added;; 11/12/22: 0%->10; 17/3/23: 10%->25; 8/6/23: 25%->70; 8/6/23: FCD:06/06/2023->12/23; 7/9/23: 70%->100 / Impacted TSs and TRs: 28.839 / WI rapporteur name: CHEN SHAN, Huawei / WI rapporteur e-mail: chenshan@huawei.com
- 1091: ; 21/9/23: 32.282 added;; 8/12/23: 0%->60; 14/3/24: 60%->100; 2/4/24: WID:SP-231151->SP-240268 / Impacted TSs and TRs: 32.240; 32.254; 32.255; 32.291; 32.298; 32.297 ; 32.282 / WI rapporteur name: Deng, Yimeng, Huawei, / WI rapporteur e-mail: dengyimeng at huawei dot com

| ID | WBS | Task | Type | Duration | Start | Finish | Complete | Remaining | Total slack | Constraint | Resources | Work | Actual work | Acronym | PCG approved | WI rapporteur name | WI rapporteur e-mail | Release | TSG approved |
| --- | --- | --- | --- | --- | --- | --- | --- | --- | --- | --- | --- | --- | --- | --- | --- | --- | --- | --- | --- |
| 1092 | 544 | Charging Aspects for NSSAA |  | 254d | 2023-03-16 A | 2024-03-03 A | 100% |  |  | finish no earlier than 2024-03-03 | S5 | 2032h | 2032h | NSSAA_CH | 50 | Gerald Görmer, MATRIXX Software | Gerald dot Goermer at Matrixx dot com | Rel-18 | 99 |
| 1093 | 545 | Management Aspects of NTN |  | 195d | 2023-03-16 A | 2023-12-12 A | 100% |  |  | finish no earlier than 2023-12-12 | S5 | 1560h | 1560h | OAM_NTN | 50 | Sun Mingrui, China Unicom | sunmr19@chinaunicom.cn | Rel-18 | 99 |
| 1094 | 546 | Management of non-public networks phase 2 |  | 254d | 2023-03-16 A | 2024-03-03 A | 100% |  |  | finish no earlier than 2024-03-03 | S5 | 2032h | 2032h | OAM_NPN_Ph2 | 50 | ZHANG, Kai, Huawei | kai.zhangkai@huawei.com | Rel-18 | 99 |
| 1095 | 547 | Rel-18 service-based aspects | milestone | 0d? | 2016-03-15 A | 2016-03-15 A | 100% |  |  | start no earlier than 2016-03-15 |  |  |  |  |  |  |  | Rel-18 |  |
| 1096 | 548 | Study on Standardising Automated Certificate Management in SBA |  | 452d | 2021-06-11 A | 2023-03-03 A | 100% |  |  | finish no earlier than 2023-03-03 | S3 | 3616h | 3616h | FS_ACM_SBA | 47 | BT, Niraj Rathod | Niraj.rathod@bt.com | Rel-18 | 92 |
| 1097 | 549 | Automated certificate management in SBA |  | 128d | 2023-03-16 A | 2023-09-09 A | 100% |  |  | finish no earlier than 2023-09-09 | S3 | 1024h | 1024h | ACM_SBA | 50 | Peinado, German, Nokia | german.peinado@nokia.com | Rel-18 | 99 |
| 1098 | 550 | Security Aspects of the 5G Service Based Architecture Phase 2 |  | 61d | 2022-12-09 A | 2023-03-03 A | 100% |  |  | finish no earlier than 2023-03-03 | S3 | 488h | 488h | 5G_eSBA_Ph2 | 50 | Anja Jerichow, Nokia | anja.jerichow@nokia.com | Rel-18 | 98 |
| 1099 | 551 | **Service Based Interface Protocol Improvements Release 18** |  | 399d | 2022-06-03 A | 2023-12-12 A | 100% |  |  |  |  | 6384h | 6384h | SBIProtoc18 | 49 | Wang Rong, China Mobile, wangrongyjy@chinamobile.com |  | Rel-18 | 96 |
| 1100 | 551.1 | CT4 aspects of SBIProtoc18 |  | 399d | 2022-06-03 A | 2023-12-12 A | 100% |  |  | finish no earlier than 2023-12-12 | C4 | 3192h | 3192h | SBIProtoc18 | 49 | Wang Rong, China Mobile, wangrongyjy@chinamobile.com |  | Rel-18 | 96 |
| 1101 | 551.2 | CT3 aspects of SBIProtoc18 |  | 399d | 2022-06-03 A | 2023-12-12 A | 100% |  |  | finish no earlier than 2023-12-12 | C3 | 3192h | 3192h | SBIProtoc18 | 49 | Wang Rong, China Mobile, wangrongyjy@chinamobile.com |  | Rel-18 | 96 |
| 1102 | 552 | Study on GBA_U Based APIs |  | 196d | 2022-06-03 A | 2023-03-03 A | 100% |  |  | finish no earlier than 2023-03-03 | C6 | 1568h | 1568h | FS_GBA_U_API | 49 | Huo Weijing, China Mobile | huoweijing@chinamobile.com | Rel-18 | 96 |
| 1103 | 553 | GBA_U Based APIs |  | 195d | 2023-06-07 A | 2024-03-03 A | 100% |  |  | finish no earlier than 2024-03-03 | C6 | 1560h | 1560h | GBA_U_APIs | 51 | Huo Weijing(China Mobile) | huoweijing@chinamobile.com | Rel-18 | 100 |
| 1104 | 554 | Study on IETF QUIC Transport for Service Based Interfaces | milestone | 0d? | 2023-12-12 A | 2023-12-12 A | 100% |  |  | finish no earlier than 2022-03-12 | C4 |  |  | FS_QUIC | 41 | Qi Caixia, Huawei | caixia.qi@huawei.com | Rel-18 | 80 |
| 1105 | 555 | Rel-18 other aspects | milestone | 0d? | 2016-03-15 A | 2016-03-15 A | 100% |  |  | start no earlier than 2016-03-15 |  |  |  |  |  |  |  | Rel-18 |  |
| 1106 | 556 | (Small) Technical Enhancements and Improvements for Rel-18 |  | 517d | 2021-03-12 A | 2023-03-03 |  | 517d | 785d | finish no earlier than 2023-03-03 |  |  |  | TEI18 | 47 |  |  | Rel-18 | 92 |
| 1107 | 557 | Lawful Interception Rel-18 |  | 653d | 2021-03-12 A | 2023-09-09 | 20% | 522.4d | 649d | finish no earlier than 2023-09-09 | S3LI | 5224h |  | LI18 | 47 | Koen Jaspers, PIDS | kbj@xs4all.nl | Rel-18 | 92 |
| 1108 | 558 | Study on Reducing Information Exposure over SBI |  | 136d | 2023-06-07 A | 2023-12-12 | 80% | 27.2d | 582d | finish no earlier than 2023-12-12 | C4 | 1088h |  | FS_RedInfExp_SBI | 51 | Varini Gupta, Samsung | varini.gupta@samsung.com | Rel-18 | 100 |
| 1109 | 559 | Limbo: code to be used for not-approved CRs related to never-approved WIDs |  | 1d | 2019-03-07 | 2019-03-07 |  |  | 1827d |  |  |  |  | Limbo | 48 |  |  |  | 95 |
| 1110 | 560 | Test - (Small) Technical Enhancements and Improvements for Rel-18 |  | 312d | 2022-01-05 A | 2023-03-16 A | 100% |  |  | finish no earlier than 2023-03-16 | R5 | 2496h | 2496h | TEI18_Test | 50 |  |  | Rel-18 | 99 |
| 1111 | 561 | --- RELEASE 17 --- | milestone | 0d? | 2016-03-15 A | 2016-03-15 A | 100% |  |  | start no earlier than 2016-03-15 |  |  |  |  |  |  |  | Rel-17 |  |
| 1112 | 562 | Rel-17 on Use of 5G by different sectors ("verticals") | milestone, manual | 0d | 2016-06-09 A | 2016-06-09 A | 100% |  |  | finish no earlier than 2016-06-09 |  |  |  |  |  |  |  | Rel-17 |  |
| 1113 | 563 | **Enhancements for cyber-physical control applications in vertical domains** |  | 201d | 2019-03-07 A | 2019-12-12 A | 100% |  |  |  |  | 2135h | 2135h | eCAV | 43 | Bahr, Michael, Siemens AG | bahr et siemens dod com | Rel-17 | 84 |
| 1114 | 563.1 | Study on eCAV |  | 130.88d | 2019-03-07 A | 2019-09-05 A | 100% |  |  |  | S1 | 1047h | 1047h | FS_eCAV | 42 | Michael Bahr, Siemens AG | bahr et siemens dod com | Rel-17 | 83 |
| 1115 | 563.2 | Stage 1 of eCAV |  | 136d | 2019-06-06 A | 2019-12-12 A | 100% |  |  | finish no earlier than 2019-12-12 | S1 | 1088h | 1088h | eCAV | 43 | Bahr, Michael, Siemens AG | bahr et siemens dod com | Rel-17 | 84 |
| 1116 | 564 | Study on enhanced support of Non-Public Networks |  | 462d | 2019-06-06 A | 2021-03-12 A | 100% |  |  | finish no earlier than 2021-03-12 | S2 | 3696h | 3696h | FS_eNPN | 43 | Peter Hedman | peter . hedman @ ericsson . com | Rel-17 | 84 |

Notes:
- 1092: ; 31/3/23: 28.204 added;; 8/6/23: 0%->10; 7/9/23: 10%->40; 8/12/23: 40%->80; 14/3/24: 80%->100 / Impacted TSs and TRs: 32.240; 32.290; 32.291; 32.298; 32.297 ; 28.204
- 1093: ; 7/9/23: 0%->30; 8/12/23: 30%->100 / Impacted TSs and TRs: 28.541; 28.552; 28.554; 28.658
- 1094: ; 8/6/23: 0%->10; 7/9/23: 10%->40; 8/12/23: 40%->65; 8/12/23: FCD:12/12/2023->/2024; 14/3/24: 65%->100 / Impacted TSs and TRs: 28.557; 28.541; 28.531; 28.533; 28.552
- 1095: -
- 1096: Was previously listed under Rel-18 but according to SA#92 report, it is Rel-17; 1/10/21: 33.876 added;; 10/3/22: WID:SP-210419->SP-220195. Rel-17->Rel-18; 12/3/22: 0%->5; 12/3/22: FCD:10/06/2022->9/22; 4/6/22: 5%->35; 12/9/22: 35%->60; 17/3/23: 60%->90...; 8/6/23: 90%->100 / Impacted TSs and TRs: 33.876
- 1097: ; 8/6/23: 0%->35; 30/6/23: WID:SP-230150->SP-230768; 7/9/23: 35%->100 / Impacted TSs and TRs: 33.310
- 1098: ; 8/6/23: 0%->95; 15/3/24: 95%->100 / Impacted TSs and TRs: 33.501
- 1099: Impacted TSs and TRs: 29.507; 29.508; 29.512; 29.514; 29.517; 29.519; 29.520; 29.521; 29.523; 29.525; 29.534; 29.535; 29.537; 29.551; 29.554; 29.557; 29.565; 29.574; 29.575; 29.576; 29.580; 29.591; 29.594; 29.675
- 1100: ; 6/6/23: Compl:25%->50% / Impacted TSs and TRs: 29.500; 29.501; 29.502; 29.503; 29.504; 29.505; 29.509; 29.510; 29.511; 29.515; 29.518; 29.524; 29.531; 29.532; 29.536; 29.540; 29.541; 29.542; 29.544; 29.550; 29.555; 29.556; 29.559; 29.562; 29.563; 29.564; 29.571; 29.572; 29.573; 29.577; 29.578; 29.579;
- 1101: ; 9/6/23: 30%->60 / Impacted TSs and TRs: 29.507; 29.508; 29.512; 29.514; 29.517; 29.519; 29.520; 29.521; 29.523; 29.525; 29.534; 29.535; 29.537; 29.551; 29.554; 29.557; 29.565; 29.574; 29.575; 29.576; 29.580; 29.591; 29.594; 29.675
- 1102: 13/7/22: 31.822 added / Impacted TSs and TRs: 31.121 ; 31.822
- 1103: ; 30/6/23: 31.122 added; / Impacted TSs and TRs: 31.102; 31.130; 31.116 ; 31.122
- 1104: 6/8/18: 29.893 added;¦10/9/18: 0%->40¦10/12/18: FCD:03/19->06/19¦10/12/18: WID:CP-181194->CP-183245¦14/3/19: 50%->75; 31/5/19: 75%->80. 02/07/20: moved Rel-16->Rel-17; 13/9/20: FCD:12/06/2019->09/21; 13/9/21: FCD:Wed 08/09/->03/22; 12/3/22:rel-17->18 / Impacted TSs and TRs: New; 29.893
- 1105: -
- 1107: 10/9/21: WID:SP-210300->SP-210830; 4/6/22: 0%->5; 12/9/22: 5%->15; 11/12/22: 15%->20; 16/3/23: FCD:03/03/2023->/2023; 16/3/23: WID:SP-210830->SP-230241. Rapporteur changed from Alex Leadbeater; 31/3/23: 33.928 added; / Impacted TSs and TRs: 33.128;33.127;33.126;33.108;33.107 ; 33.928
- 1108: 30/6/23: 29.857 added; / Impacted TSs and TRs: 29.857
- 1109: "Dummy" is a temporary code for CRs related to not-yet-approved WIDs. If a WID ended up not being approved at pleanry, then all related CRs have to be changed from "Dummy" to "Limbo"
- 1110: 8/6/23: 0%->100
- 1111: -
- 1112: -
- 1113: Impacted TSs and TRs: 22.104; 22.261
- 1114: 14/3/19: 0%->5; 31/5/19: 5%->60; 13/9/19: 60%->85; 6/12/19: 85%->95; 26/6/20: 95%->100 / Impacted TSs and TRs: New
- 1115: 31/5/19: 0%->10; 13/9/19: 10%->80; 20/9/19: WID:SP-190310->SP-190945; 6/12/19: 80%->95; 12/12/19: WID:SP-190945->SP-191043; 26/6/20: 95%->100 / Impacted TSs and TRs: 22.104; 22.261
- 1116: 8/10/19: 23.700-07 added;; 6/12/19: 0%->15; 25/3/20: WID:SP-190453->SP-200094; 25/3/20: FCD:12/03/2020->06/20; 25/3/20: 15%->35; 26/6/20: FCD:15/06/2020->09/20; 26/6/20: 35%->55; 12/9/20: 55%->75; 12/9/20: FCD:15/09/2020->12/20; 5/12/20: 75%->90; 5/12 / Impacted TSs and TRs: New ; 23.700-07

| ID | WBS | Task | Duration | Start | Finish | Complete | Constraint | Resources | Work | Actual work | Acronym | PCG approved | WI rapporteur name | WI rapporteur e-mail | Release | TSG approved | TSG stopped |
| --- | --- | --- | --- | --- | --- | --- | --- | --- | --- | --- | --- | --- | --- | --- | --- | --- | --- |
| 1117 | 565 | **Enhanced support of Non-Public Networks** | 522d | 2020-06-12 A | 2022-06-10 A | 100% |  |  | 16080h | 16080h | eNPN | 46 | Hedman, Peter, Ericsson | peter dot hedman at ericsson dot com | Rel-17 | 90 |  |
| 1118 | 565.1 | Stage 2 for eNPN | 200d | 2020-12-03 A | 2021-09-08 A | 100% | finish no earlier than 2021-09-08 | S2 | 1600h | 1600h | eNPN | 46 | Hedman, Peter, Ericsson | peter dot hedman at ericsson dot com | Rel-17 | 90 |  |
| 1119 | 565.2 | **CT aspects of eNPN** | 258d | 2021-03-18 A | 2022-03-11 A | 100% |  | ct | 8224h | 8224h | eNPN | 46 | Sedlacek, Ivo, Ericsson | ivo <dot> sedlacek <at> ericsson <dot> com | Rel-17 | 91 |  |
| 1120 | 565.2.1 | CT1 aspects of eNPN | 257d | 2021-03-18 A | 2022-03-11 A | 100% | finish no earlier than 2022-03-12 | C1 | 2056h | 2056h | eNPN | 46 | Sedlacek, Ivo, Ericsson | ivo <dot> sedlacek <at> ericsson <dot> com | Rel-17 | 91 |  |
| 1121 | 565.2.2 | CT3 aspects of eNPN | 257d | 2021-03-18 A | 2022-03-11 A | 100% | finish no earlier than 2022-03-12 | C3 | 2056h | 2056h | eNPN | 46 | Sedlacek, Ivo, Ericsson | ivo <dot> sedlacek <at> ericsson <dot> com | Rel-17 | 91 |  |
| 1122 | 565.2.3 | CT4 aspects of eNPN | 257d | 2021-03-18 A | 2022-03-11 A | 100% | finish no earlier than 2022-03-12 | C4 | 2056h | 2056h | eNPN | 46 | Sedlacek, Ivo, Ericsson | ivo <dot> sedlacek <at> ericsson <dot> com | Rel-17 | 91 |  |
| 1123 | 565.3 | Security Aspects of eNPN | 261d | 2021-06-11 A | 2022-06-10 A | 100% | finish no earlier than 2022-06-12 | S3 | 2088h | 2088h | eNPN | 47 | Jost, Christine, Ericsson | christine.jost@ericsson.com | Rel-17 | 92 |  |
| 1124 | 565.4 | Study on enhanced security support for Non-Public Networks | 521d | 2020-06-12 A | 2022-06-10 A | 100% | finish no earlier than 2022-06-12 | S3 | 4168h | 4168h | FS_eNPN_SEC | 45 | Normann, Henrik, Ericsson | henrik.normann@ericsson.com | Rel-17 | 88 |  |
| 1125 | 566 | **Audio-Visual Service Production** | 397d? | 2018-06-06 A | 2019-12-12 A | 100% |  |  | 3216h | 3216h | AVPROD | 43 | Wagdin, Ian, BBC | ian.wagdin@bbc.co.uk | Rel-17 | 84 |  |
| 1126 | 566.1 | Study on AVPROD | 266d? | 2018-06-06 A | 2019-06-12 A | 100% | finish no earlier than 2019-06-12 | S1 | 2128h | 2128h | FS_AVPROD | 41 | Roland Beutler, EBU | Roland.Beutler@swr.de | Rel-17 | 80 |  |
| 1127 | 566.2 | Stage 1 of AVPROD | 136d | 2019-06-06 A | 2019-12-12 A | 100% | finish no earlier than 2019-12-12 | S1 | 1088h | 1088h | AVPROD | 43 | Wagdin, Ian, BBC | ian.wagdin@bbc.co.uk | Rel-17 | 84 |  |
| 1128 | 567 | Study on Media Production over 5G NPN | 322d | 2021-03-18 A | 2022-06-10 A | 100% | finish no earlier than 2022-06-12 | S4 | 2576h | 2576h | FS_NPN4AVProd | 46 | Lohmar, Thorsten, Ericsson | Thorsten.Lohmar@ericsson.com | Rel-17 | 91 |  |
| 1129 | 568 | Study on application layer support for Factories of the Future in 5G network | 592d? | 2019-03-07 A | 2021-06-11 A | 100% | finish no earlier than 2021-06-12 | S6 | 4736h | 4736h | FS_FFAPP | 42 | Shao Weixiang, ZTE Corporation | shao.weixiang@zte.com.cn | Rel-17 | 82 |  |
| 1130 | 569 | Stopped - Study on enhancement of support for 5G LAN-type service | 201d | 2019-06-06 A | 2020-03-12 A | 100% | finish no earlier than 2020-03-12 | S2 | 1608h | 1608h | FS_5GLAN_enh | 43 | Runze Zhou, Huawei | zhourunze@huawei.com | Rel-17 | 84 | 96 |
| 1131 | 570 | Study on Charging Aspect of 5G LAN-type Services | 266d | 2020-12-04 A | 2021-12-10 A | 100% | finish no earlier than 2021-12-12 | S5 | 2128h | 2128h | FS_5GLAN_CH | 46 | CHEN SHAN, Huawei | chenshan@huawei.com | Rel-17 | 90 |  |
| 1132 | 571 | Charging Aspects of 5G LAN VN Group | 131d | 2021-12-10 A | 2022-06-10 A | 100% | finish no earlier than 2022-06-12 | S5 | 1048h | 1048h | 5GLAN_CH | 48 | CHEN SHAN, Huawei | chenshan@huawei.com | Rel-17 | 94 |  |
| 1133 | 572 | Complete Gap Analysis for Railways Mobile Communication System | 136d | 2019-06-06 A | 2019-12-12 A | 100% | finish no earlier than 2019-12-12 | S1 | 1088h | 1088h | MONASTERYEND | 43 | Gach, Guillaume, UIC | ext.gach@uic.org | Rel-17 | 84 |  |
| 1134 | 573 | **Enhancements to Application Architecture for the Mobile Communication System for Railways Phase 2** | 723d | 2019-06-06 A | 2022-03-11 A | 100% |  |  | 5760h | 5760h | eMONASTERY2 | 43 | Oettl, Martin, Nokia | martin(dot)oettl(at)nokia(dot)com | Rel-17 | 84 |  |
| 1135 | 573.1 | Stage 2 of eMONASTERY2 | 332d | 2019-06-06 A | 2020-09-11 A | 100% | finish no earlier than 2020-09-12 | S6 | 2656h | 2656h | eMONASTERY2 | 43 | Oettl, Martin, Nokia | martin(dot)oettl(at)nokia(dot)com | Rel-17 | 84 |  |
| 1136 | 573.2 | Stage 3 of eMONASTERY2 | 388d | 2020-09-16 A | 2022-03-11 A | 100% | finish no earlier than 2022-03-12 | C1 | 3104h | 3104h | eMONASTERY2 | 45 | Gkatzikis, Lazaros, Nokia(Nokia) | lazaros(dot)gkatzikis(at)nokia(dot)com | Rel-17 | 89 |  |
| 1137 | 574 | Study on Future Railway Mobile Communication System3 | 136d | 2019-06-06 A | 2019-12-12 A | 100% | finish no earlier than 2019-12-12 | S1 | 1088h | 1088h | FS_FRMCS3 | 43 | Gach, Guillaume, UIC, | ext.gach@uic.org | Rel-17 | 84 |  |
| 1138 | 575 | **Asset Tracking for 5G** | 331d? | 2018-09-06 A | 2019-12-12 A | 100% |  |  | 2104h | 2104h | ATRAC | 43 | Thierry Berisot, NOVAMINT | tberisot@novamint.com | Rel-17 | 85 |  |
| 1139 | 575.1 | Study on ATRAC | 202d? | 2018-09-06 A | 2019-06-14 A | 100% | finish no earlier than 2019-06-14 | S1 | 1616h | 1616h | FS_5G_ATRAC | 41 | Thierry Berisot, NOVAMINT | tberisot@novamint.com | Rel-17 | 81 |  |
| 1140 | 575.2 | Stage 1 of ATRAC | 61d | 2019-09-19 A | 2019-12-12 A | 100% | finish no earlier than 2019-12-12 | S1 | 488h | 488h | ATRAC | 43 | Thierry Berisot, NOVAMINT | tberisot@novamint.com | Rel-17 | 85 |  |

Notes:
- 1117: Impacted TSs and TRs: 23.501; 23.502; 23.503; 23.228; 23.167
- 1118: 19/3/21: 0%->20; 14/6/21: 20%->85; 14/6/21: FCD:Fri 11/06/->09/21; 13/9/21: 85%->95; 10/12/21: 95%->97; 12/3/22: 97%->100 / Impacted TSs and TRs: 23.501; 23.502; 23.503; 23.228; 23.167
- 1119: ; 10/9/21: WID:CP-210139->CP-212103 / Impacted TSs and TRs: 23.003; 23.122; 24.008; 24.167; 24.229; 24.368; 24.501; 24.526; 27.007; 29.503; 29.505; 29.509; 29.513; 29.522; 29.525; 29.561
- 1120: ; 11/6/21: 0%->20; 13/9/21: 20%->40; 13/12/21: 40%->65; 12/3/22: 65%->93; 4/6/22: 93%->99; 20/6/22: Compl:99%->100%
- 1121: ; 13/9/21: 0%->45; 13/12/21: 45%->75; 13/12/21: WID:CP-212103->CP-213072; 12/3/22: 75%->100
- 1122: ; 11/6/21: 0%->30; 13/9/21: 30%->40; 13/12/21: 40%->80; 12/3/22: 80%->98; 4/6/22: 98%->100
- 1123: ; 13/9/21: 0%->50; 13/12/21: 50%->90; 12/3/22: 90%->95; 12/3/22: FCD:10/12/2021->6/22; 4/6/22: 95%->100 / Impacted TSs and TRs: 33.501
- 1124: 28/7/20: 33.857 added;; 12/9/20: 0%->10; 5/12/20: 10%->35; 5/12/20: FCD:11/12/2020->03/20; 19/3/21: 35%->65; 19/3/21: FCD:12/03/2021->06/21; 11/6/21: 65%->75; 11/6/21: FCD:Fri 11/06/->12/21; 13/9/21: 75%->90; 12/3/22: 90%->90; 12/3/22: FCD:10/12/2021-> / Impacted TSs and TRs: 33.857
- 1125: Impacted TSs and TRs: 22.261
- 1126: 6/8/18: 22.827 added;¦10/9/18: 0%->10¦4/12/18: 10%->50¦14/12/18: WID:SP-180340->SP-181015¦14/12/18: FCD:03/19->06/19¦14/3/19: 50%->80; 31/5/19: 80%->95; 13/9/19: 95%->100 / Impacted TSs and TRs: 22.827
- 1127: 13/9/19: 0%->80; 6/12/19: 80%->100; 12/12/19: WID:SP-190304->SP-191041 / Impacted TSs and TRs: 22.261
- 1128: ; 9/4/21: 26.805 added;; 11/6/21: 0%->15; 13/9/21: 15%->30; 13/12/21: 30%->60; 12/3/22: 60%->80; 12/3/22: FCD:11/03/2022->6/22; 4/6/22: 80%->100 / Impacted TSs and TRs: New 26.805
- 1129: 14/3/19: 0%->5; 31/5/19: 5%->15; 13/9/19: 15%->20; 13/9/19: FCD:12/03/2020->09/20; 20/9/19: WID:SP-181139->SP-190724; 6/12/19: 20%->40; 26/3/20: 40%->50; 25/6/20: WID:SP-190724->; 28/6/20: 50%->60; 13/9/20: 60%->70; 13/9/20: WID:->SP-200836; 13/9/20: F / Impacted TSs and TRs: new
- 1130: 20/9/19: WID:SP-190454->SP-190626; 8/10/19: 23.762 added;; 22/3/22: Stopped at 0% (Puneet: deprioritized as part of the Rel-17 prioritization exercise) / Impacted TSs and TRs: New ; 23.762
- 1131: 21/3/21: 0%->10; 2/7/21: 28.822 added;; 13/9/21: 10%->60; 13/9/21: FCD:Fri 11/06/->12/21; 12/3/22: 60%->100 / Impacted TSs and TRs: 28.822
- 1132: ; 12/3/22: 0%->35; 22/3/22: WID:SP-211430->SP-220291; 4/6/22: 35%->100 / Impacted TSs and TRs: 32.240; 32.255; 32.291; 32.298
- 1133: 31/5/19: 0%->20; 13/9/19: 20%->80; 6/12/19: 80%->100 / Impacted TSs and TRs: 22.280; 22.281; 22.282; 22.179; 22.289
- 1134: 13/9/19: 0%->70; 6/12/19: 70%->50; 6/12/19: FCD:10/12/2019->03/20; 6/12/19: WID:SP-190565->SP-191104; 26/3/20: 50%->60; 26/3/20: FCD:12/03/2020->09/20; 28/6/20: 60%->85 / Impacted TSs and TRs: 23.280; 23.379; 23.281; 23.282; 23.283
- 1135: 13/9/19: 0%->70; 6/12/19: 70%->50; 6/12/19: FCD:10/12/2019->03/20; 6/12/19: WID:SP-190565->SP-191104; 26/3/20: 50%->60; 26/3/20: FCD:12/03/2020->09/20; 28/6/20: 60%->85; 13/9/20: 85%->100 / Impacted TSs and TRs: 23.280; 23.379; 23.281; 23.282; 23.283
- 1136: ; 5/12/20: 0%->10; 21/3/21: 10%->30; 11/6/21: 30%->50; 13/9/21: 50%->55; 13/9/21: FCD:Wed 08/09/->03/22; 13/12/21: 55%->70; 12/3/22: 70%->80; 4/6/22: 80%->98 / Impacted TSs and TRs: 24.379 ; 24.282 ; 24.481 ; 24.483 ; 24.484 ; 24.582
- 1137: 31/5/19: 0%->40; 13/9/19: 40%->80; 6/12/19: 80%->100; 25/6/20: WID:SP-190321->SP-200578 / Impacted TSs and TRs: 22.989
- 1138: Impacted TSs and TRs: 22.261
- 1139: 4/12/18: 0%->15¦14/3/19: 15%->45; 31/5/19: 45%->50; 13/9/19: 50%->100 / Impacted TSs and TRs: 22.836
- 1140: ; 13/9/19: 0%->95; 6/12/19: 95%->100 / Impacted TSs and TRs: 22.261

| ID | WBS | Task | Type | Duration | Start | Finish | Complete | Remaining | Total slack | Constraint | Resources | Work | Actual work | Acronym | PCG approved | Impacted TSs and TRs | WI rapporteur name | WI rapporteur e-mail | Release | TSG approved | Status Report |
| --- | --- | --- | --- | --- | --- | --- | --- | --- | --- | --- | --- | --- | --- | --- | --- | --- | --- | --- | --- | --- | --- |
| 1141 | 576 | **Enhancement to the 5GC LoCation Services-Phase 2** |  | 514d | 2020-03-25 A | 2022-03-11 A | 100% |  |  |  |  | 11272h | 11272h | 5G_eLCS_ph2 | 44 | 23.273 | Ming Ai, CATT | aiming@catt.cn | Rel-17 | 87 |  |
| 1142 | 576.1 | Stage 2 of 5G_eLCS_ph2 |  | 381d | 2020-03-25 A | 2021-09-08 A | 100% |  |  | finish no earlier than 2021-09-08 | S2 | 3048h | 3048h | 5G_eLCS_ph2 | 44 | 23.273 | Ming Ai, CATT | aiming@catt.cn | Rel-17 | 87 |  |
| 1143 | 576.2 | **CT aspects of 5G_eLCS_ph2** |  | 258d | 2021-03-18 A | 2022-03-11 A | 100% |  |  |  | ct | 8224h | 8224h | 5G_eLCS_ph2 | 46 |  | Chenxi Bao, CATT | baochenxi@catt.cn | Rel-17 | 91 |  |
| 1144 | 576.2.1 | CT1 aspects of 5G_eLCS_ph2 |  | 257d | 2021-03-18 A | 2022-03-11 A | 100% |  |  | finish no earlier than 2022-03-12 | C1 | 2056h | 2056h | 5G_eLCS_ph2 | 46 | 24.501; 24.571; 27.007 | Chenxi Bao, CATT | baochenxi@catt.cn | Rel-17 | 91 |  |
| 1145 | 576.2.2 | CT3 aspects of 5G_eLCS_ph2 |  | 257d | 2021-03-18 A | 2022-03-11 A | 100% |  |  | finish no earlier than 2022-03-12 | C3 | 2056h | 2056h | 5G_eLCS_ph2 | 46 | 29.522; 29.122 | Chenxi Bao, CATT | baochenxi@catt.cn | Rel-17 | 91 |  |
| 1146 | 576.2.3 | CT4 aspects of 5G_eLCS_ph2 |  | 257d | 2021-03-18 A | 2022-03-11 A | 100% |  |  | finish no earlier than 2022-03-12 | C4 | 2056h | 2056h | 5G_eLCS_ph2 | 46 | 29.515; 29.572; 24.080; 29.518; 29.503; 29.571 | Chenxi Bao, CATT | baochenxi@catt.cn | Rel-17 | 91 |  |
| 1147 | 577 | **RAN aspects of NR positioning enhancements** |  | 1375d | 2019-03-07 A | 2024-06-06 | 82% | 247.64d | 453d |  |  | 12640h | 8968h | NR_pos_enh | 46 |  | Intel |  | Rel-17 | 90 |  |
| 1148 | 577.1 | Study on NR positioning enhancements |  | 325d | 2019-03-07 A | 2020-06-03 A | 100% |  |  |  | R1 | 2600h | 2600h | FS_NR_pos_enh | 44 |  | CATT |  | Rel-17 | 86 |  |
| 1149 | 577.2 | Core part: NR positioning enhancements |  | 332d | 2020-12-14 A | 2022-03-22 A | 100% |  |  | finish no earlier than 2022-03-22 | R1 | 2656h | 2656h | NR_pos_enh-Core | 46 |  | Yi GUO, Intel Corporation | yi.guo@intel.com | Rel-17 | 90 | RP-221586 |
| 1150 | 577.3 | Perf. part: NR positioning enhancements |  | 464d | 2020-12-14 A | 2022-09-22 A | 100% |  |  | finish no earlier than 2022-09-22 | R1 | 3712h | 3712h | NR_pos_enh-Perf | 46 |  | Yi GUO, Intel Corporation | yi.guo@intel.com | Rel-17 | 90 | RP-221586 |
| 1151 | 577.4 | UE Conformance - NR Positioning Enhancements |  | 459d | 2022-09-08 A | 2024-06-06 | 38% | 284.58d | 453d | finish no earlier than 2024-06-06 | R5 | 3672h |  | NR_pos_enh-UEConTest | 49 |  | Xiaoyang TIAN, CATT | tianxiaoyang@catt.cn | Rel-17 | 97 | RP-240386 |
| 1152 | 578 | **Communication Service Requirements for Critical Medical Applications** |  | 331d? | 2018-09-06 A | 2019-12-12 A | 100% |  |  |  |  | 3224h | 3224h | CMED | 43 | 22.261; 22.104 | Lagrange, Mathieu, b<>com | mathieu.lagrange@b-com.com | Rel-17 | 84 |  |
| 1153 | 578.1 | Study on CMED |  | 267d? | 2018-09-06 A | 2019-09-13 A | 100% |  |  | finish no earlier than 2019-09-13 | S1 | 2136h | 2136h | FS_CMED | 41 | 22.826 | Mathieu Lagrange, b<>com | mathieu.lagrange@b-com.com | Rel-17 | 81 |  |
| 1154 | 578.2 | Stage 1 of CMED |  | 136d | 2019-06-06 A | 2019-12-12 A | 100% |  |  | finish no earlier than 2019-12-12 | S1 | 1088h | 1088h | CMED | 43 | 22.261; 22.104 | Lagrange, Mathieu, b<>com | mathieu.lagrange@b-com.com | Rel-17 | 84 |  |
| 1155 | 579 | Rel-17 drone/UAS/UAV/EAV | milestone, manual | 0d | 2016-06-09 A | 2016-06-09 A | 100% |  |  | finish no earlier than 2016-06-09 |  |  |  |  |  |  |  |  | Rel-17 |  |  |
| 1156 | 580 | **5G Enhancement for UAVs** |  | 332d? | 2018-09-06 A | 2019-12-13 A | 100% |  |  |  |  | 3744h | 3744h | EAV | 43 | 22.125; 22.261 | Qun Wei, China Unicom | weiqun5@chinaunicom.cn | Rel-17 | 84 |  |
| 1157 | 580.1 | Study on EAV |  | 332d? | 2018-09-06 A | 2019-12-13 A | 100% |  |  | finish no earlier than 2019-12-13 | S1 | 2656h | 2656h | FS_EAV | 41 | 22.829 | Qun Wei, China Unicom | weiqun5@chinaunicom.cn | Rel-17 | 81 |  |
| 1158 | 580.2 | Stage 1 of EAV |  | 136d | 2019-06-06 A | 2019-12-12 A | 100% |  |  | finish no earlier than 2019-12-12 | S1 | 1088h | 1088h | EAV | 43 | 26.118; 26.247¦22.125 | Qun Wei, China Unicom | weiqun5@chinaunicom.cn | Rel-17 | 84 |  |
| 1159 | 581 | Study on supporting Uncrewed Aerial Systems Connectivity, Identification, and Tracking |  | 529d | 2018-12-06 A | 2020-12-15 A | 100% |  |  | finish no earlier than 2020-12-15 | S2 | 4232h | 4232h | FS_ID_UAS_SA2 | 42 |  | Qualcomm Incorporated, Stefano Faccin | sfaccin@qti.qualcomm.com | Rel-17 | 82 |  |
| 1160 | 582 | Study on application layer support for Uncrewed Aerial System (UAS) |  | 592d | 2018-12-06 A | 2021-03-12 A | 100% |  |  | finish no earlier than 2021-03-12 | S6 | 4736h | 4736h | FS_UASAPP | 42 | new 23.755 | Niranth Amogh, Huawei | namogh@huawei.com | Rel-17 | 82 |  |
| 1161 | 583 | **Application layer support for Uncrewed Aerial System (UAS)** |  | 332d | 2020-12-04 A | 2022-03-11 A | 100% |  |  |  |  | 4224h | 4224h | UASAPP | 46 |  | Niranth Amogh, Huawei Telecommunications India | namogh@huawei.com | Rel-17 | 90 |  |
| 1162 | 583.1 | Stage 2 of Application layer support for Uncrewed Aerial System (UAS) |  | 136d | 2020-12-04 A | 2021-06-11 A | 100% |  |  | finish no earlier than 2021-06-12 | S6 | 1088h | 1088h | UASAPP | 46 | 23.434 ; new 23.255 | Niranth Amogh, Huawei Telecommunications India | namogh@huawei.com | Rel-17 | 90 |  |
| 1163 | 583.2 | CT1 Aspects of Application Layer Support for Uncrewed Aerial Systems (UAS) |  | 196d | 2021-06-11 A | 2022-03-11 A | 100% |  |  | finish no earlier than 2022-03-12 | C1 | 1568h | 1568h | UASAPP | 47 | 24.548;24.545;27.007 ; 24.257 | Lin Shu, Huawei, | shulin@huawei.com | Rel-17 | 92 |  |
| 1164 | 583.3 | CT3 Aspects of Application Layer Support for Uncrewed Aerial Systems (UAS) |  | 196d | 2021-06-11 A | 2022-03-11 A | 100% |  |  | finish no earlier than 2022-03-12 | C3 | 1568h | 1568h | UASAPP | 47 | 29.549 ; 29.257 | Lin Shu, Huawei | shulin@huawei.com | Rel-17 | 92 |  |
| 1165 | 584 | Study on security aspects of Uncrewed Aerial Systems (UAS) |  | 391d | 2020-06-12 A | 2021-12-10 A | 100% |  |  | finish no earlier than 2021-12-12 | S3 | 3128h | 3128h | FS_UAS_SEC | 45 | 33.854 | Adrian Escott, Qualcomm Incorporated | aescott@qti.qualcomm.com | Rel-17 | 88 |  |

Notes:
- 1141: 5/12/20: 0%->20; 5/12/20: FCD:17/09/2020->06/20
- 1142: 5/12/20: 0%->20; 5/12/20: FCD:17/09/2020->06/20; 19/3/21: 20%->40; 11/6/21: 40%->70; 11/6/21: FCD:Fri 11/06/->09/21; 13/9/21: 70%->95; 10/12/21: 95%->100
- 1143: 11/6/21: WID:CP-210075->CP-211090
- 1144: 13/12/21: 0%->50; 12/3/22: 50%->98; 20/6/22: Compl:98%->100%
- 1145: 13/9/21: 0%->10; 13/12/21: 10%->60; 12/3/22: 60%->100
- 1146: 11/6/21: 0%->20; 13/9/21: 20%->35; 13/12/21: 35%->75; 12/3/22: 75%->98; 4/6/22: 98%->100; 20/6/22: Compl:99%->100%
- 1147: follow-up WI of REL-17 SI FS_NR_pos_enh (not yet completed at RAN #90e) ; 7/4/21: WID:RP-202900->RP-210903
- 1148: affects: NR. compare REL-16 NR_pos WI; TR 38.8xx; 26/3/20: WID:RP-193237->RP-200218; 28/7/20: WID:RP-200218->RP-200928; 25/9/20: WID:RP-200928->RP-202094; 7/4/21: 0%->100
- 1149: follow-up WI of REL-17 SI FS_NR_pos_enh (not yet completed at RAN #90e) ; 20/6/22: FCD:12/03/2022->22/03/2022; Compl:0%->100%; Stat Rep: ->RP-221586; Rapporteur: Intel->Yi GUO, Intel Corporation; Rap eMail: ->yi.guo@intel.com;
- 1150: follow-up WI of REL-17 SI FS_NR_pos_enh ; 20/6/22: WG: R4->R1; FCD:08/09/2022->22/09/2022; Compl:0%->40%; Stat Rep: ->RP-221586; Rapporteur: Intel->Yi GUO, Intel Corporation; Rap eMail: ->yi.guo@intel.com ; ;...; 23/9/22: 100%->100
- 1151: 9/12/22: FCD:10/06/2024->31/05/2024; Compl:0%->5%; Stat Rep: ->RP-223137; Rapporteur: CATT->Xiaoyang TIAN, CATT; Rap eMail: ->tianxiaoyang@catt.cn; 17/3/23: Compl:5%->7%; Stat Rep: RP-223137->RP-230394; ...; 6/9/23: FCD:06/06/2023->06/06/2024; Compl:1...; 14/3/24: FCD:05/06/2024->06/06/2024; Compl:27%->38%; Stat Rep: RP-233001->RP-240386;
- 1153: 4/12/18: 0%->15¦14/3/19: 15%->65; 31/5/19: 65%->90; 6/12/19: 90%->100
- 1154: 13/9/19: 0%->80; 6/12/19: 80%->100
- 1155: 06/21: "unmanned" changed to "uncrewed" as per SA#91 discussions
- 1157: -; 31/5/19: 70%->90; 13/9/19: 90%->100
- 1158: 26.118¦26.247 ; 13/9/19: 0%->80; 6/12/19: 80%->100
- 1159: 25/3/20: WID:SP-181114->SP-200097; 25/3/20: 0%->25; 26/6/20: FCD:12/03/2020->09/20; 26/6/20: 25%->50; 12/9/20: 50%->70; 12/9/20: FCD:15/09/2020->12/20; 5/12/20: 70%->100
- 1160: 31/5/19: 0%->10; 13/9/19: 10%->25; 6/12/19: 25%->35; 6/12/19: FCD:13/12/2019->03/20; 25/3/20: WID:SP-181252->SP-200111; 25/3/20: FCD:12/03/2020->09/20; 28/6/20: 35%->45; 13/9/20: 45%->55; 5/12/20: 55%->75; 5/12/20: FCD:11/09/2020->03/20; 21/3/21: 75%->100
- 1161: 23.434 ; 21/3/21: 0%->25
- 1162: 21/3/21: 0%->25; 11/6/21: 25%->100; 2/7/21: 23.255 added;
- 1163: ; 2/7/21: 24.257 added;; 13/9/21: 0%->40; 13/12/21: 40%->80; 12/3/22: 80%->100
- 1164: ; 11/6/21: 0%->5; 2/7/21: 29.257 added;; 13/9/21: 5%->30; 13/12/21: 30%->75; 13/12/21: WID:CP-211111->CP-213076; 12/3/22: 75%->100; 12/3/22: WID:CP-213076->CP-220303
- 1165: 12/9/20: 0%->15; 12/9/20: FCD:15/01/2021->03/21; 5/12/20: 15%->30; 19/3/21: FCD:12/03/2021->06/21; 19/3/21: 30%->65; 11/6/21: 65%->90; 11/6/21: FCD:Fri 11/06/->12/21; 13/12/21: 90%->90; 31/3/23: 90%->100

| ID | WBS | Task | Type | Duration | Start | Finish | Complete | Remaining | Total slack | Constraint | Resources | Work | Actual work | Acronym | PCG approved | WI rapporteur name | WI rapporteur e-mail | Release | TSG approved | Status Report |
| --- | --- | --- | --- | --- | --- | --- | --- | --- | --- | --- | --- | --- | --- | --- | --- | --- | --- | --- | --- | --- |
| 1166 | 585 | **Remote Identification of Uncrewed Aerial Systems** |  | 1640d? | 2018-09-06 A | 2024-12-12 | 99% | 22.48d? | 318d |  |  | 15712h | 11968h | ID_UAS | 41 | Eddy HALL, Qualcomm incorporated | edhall@qti.qualcomm.com | Rel-17 | 81 |  |
| 1167 | 585.1 | Stage 1 of Remote Identification of Uncrewed Aerial Systems |  | 72d? | 2018-09-06 A | 2018-12-14 A | 100% |  |  | finish no earlier than 2018-12-14 | S1 | 576h | 576h | ID_UAS | 41 | Eddy HALL, Qualcomm incorporated | edhall@qti.qualcomm.com | Rel-17 | 81 |  |
| 1168 | 585.2 | (Stage 2 of) Support of Uncrewed Aerial Systems Connectivity, Identification, and Tracking |  | 200d | 2020-12-03 A | 2021-09-08 A | 100% |  |  | finish no earlier than 2021-09-08 | S2 | 1600h | 1600h | ID_UAS | 46 | Faccin, Stefano, Qualcomm Incorporated | sfaccin@qti.qualcomm.com | Rel-17 | 90 |  |
| 1169 | 585.3 | **CT aspects for ID_UAS** |  | 258d | 2021-03-18 A | 2022-03-11 A | 100% |  |  |  | ct | 8224h | 8224h | ID_UAS | 46 | Sunghoon Kim, Qualcomm Incorporated | sunghoon@qti.qualcomm.com | Rel-17 | 91 |  |
| 1170 | 585.3.1 | CT1 aspects for ID_UAS |  | 257d | 2021-03-18 A | 2022-03-11 A | 100% |  |  | finish no earlier than 2022-03-12 | C1 | 2056h | 2056h | ID_UAS | 46 | Sunghoon Kim, Qualcomm Incorporated | sunghoon@qti.qualcomm.com | Rel-17 | 91 |  |
| 1171 | 585.3.2 | CT3 aspects for ID_UAS |  | 257d | 2021-03-18 A | 2022-03-11 A | 100% |  |  | finish no earlier than 2022-03-12 | C3 | 2056h | 2056h | ID_UAS | 46 | Sunghoon Kim, Qualcomm Incorporated | sunghoon@qti.qualcomm.com | Rel-17 | 91 |  |
| 1172 | 585.3.3 | CT4 aspects for ID_UAS |  | 257d | 2021-03-18 A | 2022-03-11 A | 100% |  |  | finish no earlier than 2022-03-12 | C4 | 2056h | 2056h | ID_UAS | 46 | Sunghoon Kim, Qualcomm Incorporated | sunghoon@qti.qualcomm.com | Rel-17 | 91 |  |
| 1173 | 585.4 | Security aspects of Uncrewed Aerial Systems |  | 196d | 2021-06-11 A | 2022-03-11 A | 100% |  |  | finish no earlier than 2022-03-12 | S3 | 1568h | 1568h | ID_UAS | 47 | Escott, Adrian, Qualcomm Incorporated | aescott@qti.qualcomm.com | Rel-17 | 92 |  |
| 1174 | 585.5 | UE Conformance - Support of Uncrewed Aerial Systems Connectivity, Identification, and Tracking |  | 468d | 2023-03-03 A | 2024-12-12 | 95% | 23.4d | 318d | finish no earlier than 2024-12-12 | R5 | 3744h |  | ID_UAS-UEConTest | 50 | Yogesh Tugnawat, Qualcomm | yogesht[at]qti.qualcomm.com | Rel-17 | 99 | RP-240294 |
| 1175 | 586 | Rel-17 Satellite/Non-Terrestrial (NTN) related | milestone, manual | 0d | 2016-06-09 A | 2016-06-09 A | 100% |  |  | finish no earlier than 2016-06-09 |  |  |  |  |  |  |  | Rel-17 |  |  |
| 1176 | 587 | **Integration of satellite components in the 5G architecture** |  | 984d? | 2018-06-06 A | 2022-03-11 A | 100% |  |  |  |  | 20968h | 20968h | 5GSAT_ARCH | 44 | Cyril MICHEL, thales | cyril.michel@thalesaleniaspace.com | Rel-17 | 86 |  |
| 1177 | 587.1 | Stage 1 of 5GSAT |  | 73d? | 2018-06-06 A | 2018-09-14 A | 100% |  |  | finish no earlier than 2018-09-14 | S1 | 584h | 584h | 5GSAT | 41 | MICHEL, Cyril, Thales | cyril.michel@thalesaleniaspace.com | Rel-17 | 80 |  |
| 1178 | 587.2 | Study on architecture aspects for using satellite access in 5G |  | 537d? | 2018-06-06 A | 2020-06-25 A | 100% |  |  | finish no earlier than 2020-06-25 | S2 | 4296h | 4296h | FS_5GSAT_ARCH | 41 | MICHEL, Cyril | cyril.michel@thalesaleniaspace.com | Rel-17 | 80 |  |
| 1179 | 587.3 | (Stage 2 of) Integration of satellite components in the 5G architecture |  | 459d | 2019-12-06 A | 2021-09-08 A | 100% |  |  | finish no earlier than 2021-09-08 | S2 | 3672h | 3672h | 5GSAT_ARCH | 44 | Cyril MICHEL, thales | cyril.michel@thalesaleniaspace.com | Rel-17 | 86 |  |
| 1180 | 587.4 | **CT aspects of 5GC architecture for satellite networks** |  | 389d | 2020-09-16 A | 2022-03-11 A | 100% |  |  |  | ct | 12416h | 12416h | 5GSAT_ARCH-CT | 45 | Catovic, Amer, Qualcomm Incorporated | amerc@qti.qualcomm.com | Rel-17 | 89 |  |
| 1181 | 587.4.1 | CT1 aspects of 5GC architecture for satellite networks |  | 388d | 2020-09-16 A | 2022-03-11 A | 100% |  |  | finish no earlier than 2022-03-12 | C1 | 3104h | 3104h | 5GSAT_ARCH-CT | 45 | Catovic, Amer, Qualcomm Incorporated | amerc@qti.qualcomm.com | Rel-17 | 89 |  |
| 1182 | 587.4.2 | CT3 aspects of 5GC architecture for satellite networks |  | 258d | 2020-09-16 A | 2021-09-10 A | 100% |  |  | finish no earlier than 2021-09-12 | C3 | 2064h | 2064h | 5GSAT_ARCH-CT | 45 | Catovic, Amer, Qualcomm Incorporated | amerc@qti.qualcomm.com | Rel-17 | 89 |  |
| 1183 | 587.4.3 | CT4 aspects of 5GC architecture for satellite networks |  | 388d | 2020-09-16 A | 2022-03-11 A | 100% |  |  | finish no earlier than 2022-03-12 | C4 | 3104h | 3104h | 5GSAT_ARCH-CT | 45 | Catovic, Amer, Qualcomm Incorporated | amerc@qti.qualcomm.com | Rel-17 | 89 |  |
| 1184 | 587.4.4 | CT6 aspects of 5GC architecture for satellite networks |  | 130d | 2021-09-13 A | 2022-03-11 A | 100% |  |  | start no earlier than 2021-09-13 | C6 | 1040h | 1040h | 5GSAT_ARCH-CT | 47 | Catovic, Amer, Qualcomm Incorporated | amerc@qti.qualcomm.com | Rel-17 | 93 |  |
| 1185 | 588 | **Solutions for NR to support non-terrestrial networks (NTN)** |  | 1173d | 2019-12-16 A | 2024-06-06 | 92% | 91.17d | 453d |  |  | 16056h | 11896h | NR_NTN_solutions | 44 | Thales |  | Rel-17 | 86 |  |
| 1186 | 588.1 | Core part: Solutions for NR for NTN |  | 646d | 2019-12-16 A | 2022-06-06 A | 100% |  |  | finish no earlier than 2022-06-06 | R4 | 5168h | 5168h | NR_NTN_solutions-Core | 44 | Nicolas Chuberre, Thales | nicolas.chuberre@thalesaleniaspace.com | Rel-17 | 86 | RP-230115 |
| 1187 | 588.2 | Perf. Part: Solutions for NR for NTN |  | 841d | 2019-12-16 A | 2023-03-03 A | 100% |  |  | finish no earlier than 2023-03-03 | R4 | 6728h | 6728h | NR_NTN_solutions-Perf | 44 | Nicolas Chuberre, Thales | nicolas.chuberre@thalesaleniaspace.com | Rel-17 | 86 | RP-230115 |
| 1188 | 588.3 | UE Conformance - Solutions for NR to support non-terrestrial networks (NTN) plus CT aspects |  | 520d | 2022-06-15 A | 2024-06-06 | 70% | 156d | 453d | finish no earlier than 2024-06-06 | R5 | 4160h |  | NR_NTN_solutions_plus_CT-UEConTest | 49 | Vijay Balasubramanian, Qualcomm | vijayb[at]qti.qualcomm.com | Rel-17 | 96 | RP-240339 |
| 1189 | 589 | **NB-IoT/eMTC support for Non-Terrestrial Networks** |  | 711d | 2021-06-15 A | 2024-03-01 | 99% | 0d | 0d |  | R1 | 14080h | 10536h | LTE_NBIOT_eMTC_NTN | 47 | MediaTek |  | Rel-17 | 92 |  |
| 1190 | 589.1 | Core part: NB-IoT/eMTC support for Non-Terrestrial Networks |  | 267d | 2021-06-15 A | 2022-06-22 A | 100% |  |  | finish no earlier than 2022-06-22 | R1 | 2136h | 2136h | LTE_NBIOT_eMTC_NTN-Core | 47 | Gilles Charbit, MediaTek | Gilles.charbit@mediatek.com | Rel-17 | 92 | RP-221546 |
| 1191 | 589.2 | UE Conformance - NB-IoT/eMTC support for Non-Terrestrial Networks (NTN) including EPS aspects |  | 449d | 2022-06-15 A | 2024-03-01 A | 100% |  |  | finish no earlier than 2024-03-01 | R5 | 3592h | 3592h | LTE_NBIOT_eMTC_NTN_plus_EPS-UEConTest | 49 | Daiwei Zhou, MediaTek Inc. | daiwei.zhou@mediatek.com | Rel-17 | 96 | RP-240442 |
| 1192 | 589.3 | Architecture support for NB-IoT/eMTC Non-Terrestrial Networks in EPS |  | 66d | 2021-09-10 A | 2021-12-10 A | 100% |  |  | finish no earlier than 2021-12-12 | S2 | 528h | 528h | IoT_SAT_ARCH_EPS | 47 | SEBIRE, Guillaume, MediaTek Inc. | guillaume dot sebire at mediatek dot com | Rel-17 | 93 |  |
| 1193 | 589.4 | CT1 aspects of NB-IoT/eMTC Non-Terrestrial Networks in EPS |  | 67d | 2021-12-13 A | 2022-03-15 A | 100% |  |  | finish no earlier than 2022-03-15 | C1 | 536h | 536h | IoT_SAT_ARCH_EPS | 48 | NIEMI, Marko, MediaTek Inc., | marko.niemi at mediatek dot com | Rel-17 | 94 |  |
| 1194 | 589.5 | CT3 aspects of NB-IoT/eMTC Non-Terrestrial Networks in EPS |  | 67d | 2021-12-13 A | 2022-03-15 A | 100% |  |  | start no earlier than 2021-12-13 | C3 | 536h | 536h | IoT_SAT_ARCH_EPS | 48 | NIEMI, Marko, MediaTek Inc., | marko.niemi at mediatek dot com | Rel-17 | 95 |  |
| 1195 | 589.6 | CT4 aspects of NB-IoT/eMTC Non-Terrestrial Networks in EPS |  | 67d | 2021-12-13 A | 2022-03-15 A | 100% |  |  | start no earlier than 2021-12-13 | C4 | 536h | 536h | IoT_SAT_ARCH_EPS | 48 | NIEMI, Marko, MediaTek Inc., | marko.niemi at mediatek dot com | Rel-17 | 95 |  |
| 1196 | 589.7 | CT6 aspects of NB-IoT/eMTC Non-Terrestrial Networks in EPS |  | 67d | 2021-12-13 A | 2022-03-15 A | 100% |  |  | start no earlier than 2021-12-13 | C6 | 536h | 536h | IoT_SAT_ARCH_EPS | 48 | NIEMI, Marko, MediaTek Inc., | marko.niemi at mediatek dot com | Rel-17 | 95 |  |
| 1197 | 590 | Study on management and orchestration aspects with integrated satellite components in a 5G network |  | 526.88d | 2019-03-07 A | 2021-03-12 A | 100% |  |  | finish no earlier than 2021-03-12 | S5 | 4215h | 4215h | FS_5GSAT_MO | 42 | Floris Drijver, TNO | floris.drijver@tno.nl | Rel-17 | 83 |  |
| 1198 | 591 | Study on NB-IoT/eMTC support for NTN |  | 392d | 2019-12-16 A | 2021-06-15 A | 100% |  |  | finish no earlier than 2021-06-15 | R1 | 3136h | 3136h | FS_LTE_NBIOT_eMTC_NTN | 44 | MediaTek |  | Rel-17 | 86 |  |
| 1199 | 592 | Rel-17 IoT related | milestone, manual | 0d | 2016-06-09 A | 2016-06-09 A | 100% |  |  | finish no earlier than 2016-06-09 |  |  |  |  |  |  |  | Rel-17 |  |  |
| 1200 | 593 | Study on enhanced support of Industrial IoT |  | 387d | 2019-09-19 A | 2021-03-12 A | 100% |  |  | finish no earlier than 2021-03-12 | S2 | 3096h | 3096h | FS_IIoT | 43 | Nokia, Devaki Chandramouli, | devaki.chandramouli@nokia.com | Rel-17 | 85 |  |
| 1201 | 594 | Study on security for enhanced support of Industrial IoT |  | 261d | 2020-06-12 A | 2021-06-11 A | 100% |  |  | finish no earlier than 2021-06-12 | S3 | 2088h | 2088h | FS_IIoT_SEC | 45 | Nokia, Anja Jerichow | anja.jerichow@nokia.com | Rel-17 | 88 |  |
| 1202 | 595 | Security for enhanced support of Industrial IoT |  | 6d | 2021-06-11 A | 2021-06-18 A | 100% |  |  | finish no earlier than 2021-06-20 | S3 | 48h | 48h | IIoT_SEC | 47 | Nokia, Anja Jerichow | anja.jerichow@nokia.com | Rel-17 | 92 |  |

Notes:
- 1167: 10/9/18: 0%->5¦4/12/18: 5%->100. Initially Rel-16 / Impacted TSs and TRs: 22.125
- 1168: 19/3/21: 0%->15; 14/6/21: 15%->80; 14/6/21: FCD:Fri 11/06/->09/21; 13/9/21: 80%->98; 10/12/21: 98%->100 / Impacted TSs and TRs: 23.501; 23.502; 23.503; 23.401
- 1169: ; 11/6/21: WID:CP-210287->CP-211112 / Impacted TSs and TRs: 24.501; 24.301; 24.008; 27.007; 29.502; 29.503; 29.504; 29.505; 29.510; 29.518; 29.571; 29.274; 29.522; 29.122; 29.512; 29.513; 29.514; 29.561; 29.519
- 1170: ; 11/6/21: 0%->20; 13/9/21: 20%->30; 13/12/21: 30%->70; 12/3/22: 70%->100
- 1171: ; 2/7/21: 29.255 added;; 2/7/21: 29.257 added;; 13/9/21: 0%->20; 13/12/21: 20%->80; 12/3/22: 80%->100 / Impacted TSs and TRs: 29.255; 29.257
- 1172: ; 11/6/21: 0%->20; 13/9/21: 20%->30; 13/12/21: 30%->80; 12/3/22: 80%->100
- 1173: 1/10/21: 33.256 added;; 13/12/21: 0%->50; 13/12/21: FCD:Fri 10/12/->03/22; 12/3/22: 50%->100 / Impacted TSs and TRs: 33.256
- 1174: ; 7/6/23: Compl:0%->6%; 7/6/23: CD:12/12/2024->12/12/2023; 6/9/23: Compl:6%->40%; Stat Rep: ->RP-231997; Rapporteur: Qualcomm->Yogesh Tugnawat, Qualcomm; Rap eMail: ->yogesht[at]qti.qualcomm.com; ; 14/3/24: FCD:12/12/2023->12/12/2024; Compl:40%->95%; Stat Rep: RP-231997->RP-240294;
- 1175: -
- 1176: Impacted TSs and TRs: 23.501; 23.502; 23.503
- 1177: 10/9/18: 0%->95¦4/12/18: 95%->100. 09/20: moved to Rel-17 since St 2 and 3 are Rel-17 / Impacted TSs and TRs: 22.261
- 1178: 10/9/18: 0%->15¦10/9/18: FCD:06/19->03/19¦7/12/18: 15%->35¦14/12/18: WID:SP-180505->SP-181253¦14/12/18: FCD:03/19->09/19¦14/3/19: 35%->50; 5/6/19: 50%->60; 13/9/19: 60%->70. Moved to R17.; 6/12/19: 70%->85; 26/6/20: FCD:12/09/2019->06/20; 26/6/20: 85%- / Impacted TSs and TRs: New
- 1179: 12/9/20: 0%->10; 12/9/20: FCD:11/09/2020->03/21; 5/12/20: 10%->50; 19/3/21: FCD:12/03/2021->06/21; 19/3/21: 50%->75; 11/6/21: 75%->98; 11/6/21: FCD:Fri 11/06/->09/21; 13/9/21: 98%->99; 10/12/21: 99%->100 / Impacted TSs and TRs: 23.501; 23.502; 23.503
- 1180: ; 25/9/20: WID:CP-202189->CP-202244; 5/12/20: 0%->20; 21/3/21: 20%->25; 11/6/21: WID:CP-202244->CP-210149 / Impacted TSs and TRs: 23.122; 24.501; 24.008; 24.301
- 1181: ; 25/9/20: WID:CP-202189->CP-202244; 5/12/20: 0%->20; 21/3/21: 20%->25; 11/6/21: 25%->80; 13/9/21: 80%->60; 13/12/21: 60%->75; 12/3/22: FCD:10/09/2021->3/22; 12/3/22: 75%->85; 4/6/22: 85%->100 / Impacted TSs and TRs: 23.122; 24.501; 24.008; 24.301
- 1182: ; 25/9/20: WID:CP-202189->CP-202244; 5/12/20: 0%->20; 21/3/21: 20%->25; 11/6/21: 25%->80; 11/6/21: 0%->60; 13/9/21: 60%->80; 13/12/21: 80%->95; 12/3/22: 95%->100 / Impacted TSs and TRs: 23.122; 24.501; 24.008; 24.301
- 1183: ; 25/9/20: WID:CP-202189->CP-202244; 5/12/20: 0%->20; 21/3/21: 20%->25; 11/6/21: 0%->80; 13/9/21: FCD:Fri 10/09/->03/22; 13/12/21: 80%->90; 12/3/22: 90%->100 / Impacted TSs and TRs: 23.122; 24.501; 24.008; 24.301
- 1184: CT6 aspects introduced as per CT6 report in CP-212127; 12/3/22: 0%->96; 4/6/22: 96%->97
- 1185: affects: NR. Follow-up WI of REL-16 SI FS_NR_NTN_solutions; 28/7/20: WID:RP-193234->RP-201256; 6/1/21: WID:RP-201256->RP-202908; 7/4/21: WID:RP-202908->RP-210908; 1/10/21: 38.108 & 38.181 added;; 5/4/22: WID:RP-210908->RP-220208 / Impacted TSs and TRs: 38.108; 38.181
- 1186: affects: NR. follow-up WI of REL-16 SI FS_NR_NTN_solutions; 1/10/21: 38.863 added;; 7/1/22: 38.101-5 added ; ; 6/6/22: Compl:90%->0% ; 20/6/22: Compl:0%->100%; Stat Rep: RP-221168->RP-221168 / 1745; Rapporteur: Thales->Nicolas Chuberre, Thales; Rap e...; 17/3/23: WID:RP-222556->RP-221169 / Impacted TSs and TRs: 38.863; 38.101-5
- 1187: affects: NR.; ; 20/6/22: WG: R4->R2; FCD:12/09/2022->22/12/2022; Compl:40%->20%; WID: RP-220208->RP-213691; Stat Rep: RP-220132->RP-221168 / 1745; Rapporteur: Thales->Nicolas Chuberre, Thales; Rap eMail: ->nicolas.chuberre@thalesaleniaspace.com; ;...;...; 17/3/23: FCD:28/02/2023->03/03/2023; Compl:98%->100%; Stat Rep: RP-222739->RP-230115;
- 1188: 9/9/22: Comp...; 23/9/22: WID:RP-221241->RP-222537; 9/12/22: FCD:23/12/2022->01/12/2023; Compl:5%->13%; WID: RP-222537->RP-221241; Stat Rep: ->RP-223386; Rapporteur: Qualcomm->Vijay Balasubramanian, Qualcomm; Rap eMail: ->vijayb[at]qti.qual...; 14/3/24: FCD:12/12/2023->06/06/2024; Compl:50%->70%; WID: RP-233929->RP-221241; Stat Rep: RP-232016->RP-240339; / Impacted TSs and TRs: 38.521-5
- 1189: follow-up WI of REL-17 SI FS_LTE_NBIOT_eMTC_NTN; no Perf. part
- 1190: follow-up WI of REL-17 SI FS_LTE_NBIOT_eMTC_NTN; no Perf. part ; 20/6/22: Release: Rel-17->Rel-18; Rapporteur: MediaTek->Gilles Charbit, MediaTek; Rap eMail: ->Gilles.charbit@mediatek.com;
- 1191: 9/9/22: Comp...; 9/12/22: FCD:23/09/2022->01/09/2023; Compl:45%->95%; Stat Rep: ->RP-223229; Rapporteur: MediaTek->Daiwei Zhou, MediaTek Inc.; Rap eMail: ->daiwei.zhou@mediatek.com; 17/3/23: FCD:09/09/2023->08/09/2023; Compl:95%->96%; Sta.....; 14/3/24: Compl:99%->100%; Stat Rep: RP-233249->RP-240442;
- 1192: ; 7/1/22: WID:SP-211124->SP-211306; 7/1/22: 0%->95; 12/3/22: 95%->100 / Impacted TSs and TRs: 23.203; 23.271; 23.401; 23.682
- 1193: ; 12/3/22: 0%->20; 4/6/22: 20%->80;; 20/6/22: FCD:13/12/2021->15/03/2022Compl:80%->95% / Impacted TSs and TRs: 23.122; 23.008; 24.008; 24.301; 27.007; 29.212; 29.272; 29.274; 31.102; 31.111
- 1194: ; 12/3/22: 0%->20; 12/3/22: 0%->100 / Impacted TSs and TRs: 23.122; 23.008; 24.008; 24.301; 27.007; 29.212; 29.272; 29.274; 31.102; 31.111
- 1195: ; 12/3/22: 0%->20; 12/3/22: 0%->100 / Impacted TSs and TRs: 23.122; 23.008; 24.008; 24.301; 27.007; 29.212; 29.272; 29.274; 31.102; 31.111
- 1196: ; 12/3/22: 0%->20; 4/6/22: 0%->80 / Impacted TSs and TRs: 23.122; 23.008; 24.008; 24.301; 27.007; 29.212; 29.272; 29.274; 31.102; 31.111
- 1197: 31/5/19: 0%->10; 31/5/19: 0%->10; 13/9/19: 10%->30; 26/3/20: 30%->60; 26/3/20: FCD:05/12/2019->06/20; 28/6/20: 60%->65; 13/9/20: 65%->70; 13/9/20: FCD:12/06/2020->12/20; 5/12/20: 70%->90; 5/12/20: FCD:15/12/2020->03/20; 21/3/21: 90%->100 / Impacted TSs and TRs: New
- 1198: affects: LTE. connecting LTE NB-IoT and LTE eMTC to NTN of NR; TR 36.7xx; 25/9/20: 36.763 added;; 6/1/21: WID:RP-193235->RP-202689; 2/7/21: 0%->100 / Impacted TSs and TRs: 36.763
- 1199: -
- 1200: ; 8/10/19: 23.700-20 added;; 6/12/19: 0%->20; 25/3/20: WID:SP-190932->SP-200298; 25/3/20: FCD:12/03/2020->06/20; 25/3/20: 20%->40; 26/6/20: FCD:15/06/2020->09/20; 26/6/20: 40%->55; 12/9/20: 55%->75; 12/9/20: FCD:15/09/2020->12/20; 5/12/20: 75%->95; 5 / Impacted TSs and TRs: New ; 23.700-20
- 1201: 28/7/20: 33.851 added;; 12/9/20: 0%->15; 5/12/20: 15%->60; 5/12/20: FCD:11/12/2020->06/20; 19/3/21: 60%->90; 11/6/21: 90%->100 / Impacted TSs and TRs: 33.851
- 1202: ; 24/3/22: 0%->100 / Impacted TSs and TRs: 33.501

| ID | WBS | Task | Type | Duration | Start | Finish | Complete | Remaining | Total slack | Constraint | Resources | Work | Actual work | Acronym | PCG approved | WI rapporteur name | WI rapporteur e-mail | Release | TSG approved | Status Report |
| --- | --- | --- | --- | --- | --- | --- | --- | --- | --- | --- | --- | --- | --- | --- | --- | --- | --- | --- | --- | --- |
| 1203 | 596 | **Support of Enhanced Industrial IIoT** |  | 333d | 2020-12-03 A | 2022-03-11 A | 100% |  |  |  |  | 9824h | 9824h | IIoT | 46 | Devaki Chandramouli, Nokia | Devaki.chandramouli@nokia.com | Rel-17 | 90 |  |
| 1204 | 596.1 | Stage 2 for IIoT |  | 200d | 2020-12-03 A | 2021-09-08 A | 100% |  |  | finish no earlier than 2021-09-08 | S2 | 1600h | 1600h | IIoT | 46 | Devaki Chandramouli, Nokia | Devaki.chandramouli@nokia.com | Rel-17 | 90 |  |
| 1205 | 596.2 | **CT aspects of support of enhanced Industrial IoT** |  | 258d | 2021-03-18 A | 2022-03-11 A | 100% |  |  |  | ct | 8224h | 8224h | IIoT | 46 | Won, Sung Hwan, Nokia | sung.won@nokia.com | Rel-17 | 91 |  |
| 1206 | 596.2.1 | CT1 aspects of support of enhanced Industrial IoT |  | 257d | 2021-03-18 A | 2022-03-11 A | 100% |  |  | finish no earlier than 2022-03-12 | C1 | 2056h | 2056h | IIoT | 46 | Won, Sung Hwan, Nokia | sung.won@nokia.com | Rel-17 | 91 |  |
| 1207 | 596.2.2 | CT3 aspects of support of enhanced Industrial IoT |  | 257d | 2021-03-18 A | 2022-03-11 A | 100% |  |  | finish no earlier than 2022-03-12 | C3 | 2056h | 2056h | IIoT | 46 | Won, Sung Hwan, Nokia | sung.won@nokia.com | Rel-17 | 91 |  |
| 1208 | 596.2.3 | CT4 aspects of support of enhanced Industrial IoT |  | 257d | 2021-03-18 A | 2022-03-11 A | 100% |  |  | finish no earlier than 2022-03-12 | C4 | 2056h | 2056h | IIoT | 46 | Won, Sung Hwan, Nokia | sung.won@nokia.com | Rel-17 | 91 |  |
| 1209 | 597 | Charging enhancements for 5G CIoT |  | 131d | 2021-12-10 A | 2022-06-10 A | 100% |  |  | finish no earlier than 2022-06-12 | S5 | 1048h | 1048h | 5G_CIoT_CH | 48 | Zhu, Lei, Huawei | Lei.zhu@huawei.com | Rel-17 | 94 |  |
| 1210 | 598 | **Additional enhancements for NB-IoT and LTE-MTC** |  | 927d | 2019-03-07 A | 2022-09-22 A | 100% |  |  |  |  | 7936h | 7936h | NB_IOTenh4_LTE_eMTC6 | 44 | Huawei |  | Rel-17 | 86 |  |
| 1211 | 598.1 | Core part: Additional enhancements for NB-IoT and LTE-MTC |  | 66d | 2021-12-21 A | 2022-03-22 A | 100% |  |  | finish no earlier than 2022-03-22 | R1 | 528h | 528h | NB_IOTenh4_LTE_eMTC6-Core | 44 | Yubo YANG Emre YAVUZ, Huawei Ericsson | yangyubo1@huawei.com emre.yavuz@ericsson.com | Rel-17 | 86 | RP-221499 |
| 1212 | 598.2 | Perf. part: Additional enhancements for NB-IoT and LTE-MTC |  | 926d | 2019-03-07 A | 2022-09-22 A | 100% |  |  | start no earlier than 2019-03-07 | R1 | 7408h | 7408h | NB_IOTenh4_LTE_eMTC6-Perf | 44 | Yubo YANG Emre YAVUZ, Huawei Ericsson | yangyubo1@huawei.com emre.yavuz@ericsson.com | Rel-17 | 86 | RP-221499 |
| 1213 | 599 | **NR small data transmissions in INACTIVE state** |  | 1173d | 2019-12-16 A | 2024-06-06 | 99% | 16.04d | 453d |  |  | 15208h | 11048h | NR_SmallData_INACTIVE | 44 | ZTE |  | Rel-17 | 86 |  |
| 1214 | 599.1 | Core part: NR small data transmissions in INACTIVE state |  | 592d | 2019-12-16 A | 2022-03-22 A | 100% |  |  | finish no earlier than 2022-03-22 | R2 | 4736h | 4736h | NR_SmallData_INACTIVE-Core | 44 | Eswar Vutukuri, ZTE Corporation | eswar.vutukuri@zte.com.cn | Rel-17 | 86 | RP-221309 |
| 1215 | 599.2 | Perf. part: NR small data transmissions in INACTIVE state |  | 789d | 2019-12-16 A | 2022-12-21 A | 100% |  |  | finish no earlier than 2022-12-22 | R2 | 6312h | 6312h | NR_SmallData_INACTIVE-Perf | 44 | Eswar Vutukuri, ZTE Corporation | eswar.vutukuri@zte.com.cn | Rel-17 | 86 | RP-221309 |
| 1216 | 599.3 | UE Conformance - NR small data transmissions in INACTIVE state |  | 520d | 2022-06-15 A | 2024-06-06 | 95% | 26d | 453d | finish no earlier than 2024-06-06 | R5 | 4160h |  | NR_SmallData_INACTIVE-UEConTest | 49 | Yogesh Tugnawat, Qualcomm | yogesht[at]qti.qualcomm.com | Rel-17 | 96 | RP-240293 |
| 1217 | 600 | **Enhanced Industrial Internet of Things (IoT) and ultra-reliable and low latency communication (URLLC) support for NR** |  | 1044d | 2019-12-16 A | 2023-12-12 A | 100% |  |  |  |  | 12896h | 12896h | NR_IIOT_URLLC_enh | 44 | Nokia |  | Rel-17 | 86 |  |
| 1218 | 600.1 | Core part: Enhanced IoT and URLLC support for NR |  | 577d | 2019-12-16 A | 2022-03-01 A | 100% |  |  | finish no earlier than 2022-03-22 | R2 | 4616h | 4616h | NR_IIOT_URLLC_enh-Core | 44 | Chunli Wu, Nokia | Chunli.wu@nokia-sbell.com | Rel-17 | 86 | RP-223027 |
| 1219 | 600.2 | Perf. Part: Enhanced IoT and URLLC support for NR |  | 644d | 2020-06-15 A | 2022-12-01 A | 100% |  |  | finish no earlier than 2022-12-01 | R2 | 5152h | 5152h | NR_IIOT_URLLC_enh-Perf | 44 | Chunli Wu, Nokia | Chunli.wu@nokia-sbell.com | Rel-17 | 86 | RP-223027 |
| 1220 | 600.3 | UE Conformance - Enhanced Industrial Internet of Things (IoT) and ultra-reliable and low latency communication (URLLC) support for NR |  | 391d | 2022-06-15 A | 2023-12-12 A | 100% |  |  | finish no earlier than 2023-12-12 | R5 | 3128h | 3128h | NR_IIOT_URLLC_enh-UEConTest | 49 | Matti Kangas, Nokia, Nokia Shanghai Bell | matti.kangas@nokia.com | Rel-17 | 96 | RP-232885 |
| 1221 | 601 | Rel-17 V2V/D2D/Sidelink related | milestone, manual | 0d | 2016-06-09 A | 2016-06-09 A | 100% |  |  | finish no earlier than 2016-06-09 |  |  |  |  |  |  |  | Rel-17 |  |  |
| 1222 | 602 | **NR Sidelink enhancement** |  | 1240d | 2019-12-16 A | 2024-09-09 | 71% | 364.71d | 386d |  |  | 15168h | 10472h | NR_SL_enh | 44 | LG Electronics |  | Rel-17 | 86 |  |
| 1223 | 602.1 | Core part: NR Sidelink enhancement |  | 585d | 2019-12-16 A | 2022-03-11 A | 100% |  |  | finish no earlier than 2022-03-22 | R1 | 4680h | 4680h | NR_SL_enh-Core | 44 | LG Electronics |  | Rel-17 | 86 | RP-220520 |
| 1224 | 602.2 | Perf. part: NR Sidelink enhancement |  | 724d | 2019-12-16 A | 2022-09-22 A | 100% |  |  | finish no earlier than 2022-09-22 | R4 | 5792h | 5792h | NR_SL_enh-Perf | 44 | Seungmin Lee, LG Electronics | Edison.lee@lge.com | Rel-17 | 86 | RP-221186 |
| 1225 | 602.3 | UE Conformance - NR Sidelink enhancement |  | 587d | 2022-06-15 A | 2024-09-09 | 5% | 557.65d | 386d | finish no earlier than 2024-09-09 | R5 | 4696h |  | NR_SL_enh-UEConTest | 49 | Xiaozhong CHEN, CATT | chenxiaozhong@catt.cn | Rel-17 | 96 | RP-240387 |
| 1226 | 603 | Study on NR Sidelink relay |  | 197d | 2019-12-16 A | 2020-09-15 A | 100% |  |  | finish no earlier than 2020-09-15 | R2 | 1576h | 1576h | FS_NR_SL_relay | 44 | OPPO |  | Rel-17 | 86 |  |
| 1227 | 604 | Study on enhancements to application layer support for V2X services |  | 267d | 2019-06-06 A | 2020-06-12 A | 100% |  |  | finish no earlier than 2020-06-12 | S6 | 2136h | 2136h | FS_eV2XAPP | 43 | Niranth Amogh, Huawei Telecommunications India | namogh@huawei.com | Rel-17 | 84 |  |

Notes:
- 1204: 19/3/21: 0%->35; 11/6/21: 35%->90; 11/6/21: FCD:Fri 11/06/->09/21; 13/9/21: 90%->100 / Impacted TSs and TRs: 23.501; 23.502; 23.503
- 1205: ; 10/9/21: WID:CP-211114->CP-212100 / Impacted TSs and TRs: 24.501; 24.519; 24.535; 29.512; 29.513; 29.514; 29.519; 29.522; 29.591; 29.244
- 1206: ; 11/6/21: 0%->65; 2/7/21: 24.539 added;; 13/9/21: 65%->90; 13/12/21: 90%->95; 12/3/22: 95%->100 / Impacted TSs and TRs: 24.539
- 1207: ; 11/6/21: 0%->45; 11/6/21: WID:CP-210279->CP-211114; 13/9/21: 45%->65; 1/10/21: 29.565 added;; 13/12/21: 65%->85; 12/3/22: 85%->98; 4/6/22: 98%->100 / Impacted TSs and TRs: 29.565
- 1208: ; 11/6/21: 0%->60; 13/9/21: 60%->90; 13/12/21: 90%->95; 12/3/22: 95%->100
- 1209: ; 12/3/22: 0%->60; 4/6/22: 60%->100 / Impacted TSs and TRs: 32.255; 32.291; 32.298
- 1210: affects: LTE. compare NB_IOT, LTE_MTCe2_L1 in REL-13,NB_IOTenh, LTE_feMTC in REL-14, WTC; 28/7/20: WID:RP-193264->RP-201306; 2/7/21: WID:RP-201306->RP-211340; 5/4/22: WID:RP-211340->RP-220529
- 1211: affects: LTE. compare NB_IOT, LTE_MTCe2_L1 in REL-13,NB_IOTenh, LTE_feMTC in REL-14, WTC; 13/9/21: Com ; 20/6/22: Rapporteur: Huawei->Yubo YANG Emre YAVUZ, Huawei Ericsson; Rap eMail: ->yangyubo1@huawei.com emre.yavuz@ericsson.com20/6/22: 1...
- 1212: affects: LTE.; 13/9/21: CD:Wed 15/12/21->Wed 22/09/21 ; 22/3/22: Compl:0%->30% ; 20/6/22: WG: R4->R1; Rapporteur: Huawei->Yubo YANG Emre YAVUZ, Huawei Ericsson; Rap eMail: ->yangyubo1@huawei.com emre.yavuz@ericsson.com20/6/22: 0%->70; 20/6/22...
- 1213: affects: NR.; 28/7/20: WID:RP-193252->RP-201305; 7/4/21: WID:RP-201305->RP-210870; 29/9/21: WID:RP-210870->RP-212594; 23/9/22: WID:RP-212594->RP-222364
- 1214: affects: NR.; 13/9/21: Compl:0%->50%; 13/9/21: CD:Tue 15/06/21->Tue 22/03/22; ; 20/6/22: Rapporteur: ZTE->Eswar Vutukuri, ZTE Corporation; Rap eMail: ->eswar.vutukuri@zte.com.cn;
- 1215: affects: NR.; 13/9/21: CD:Wed 15/12/21->Wed 22/09/21; 13/9/21: Stat Rep: ->RP-211871; 22/3/22: CD:22/09/2021->12/09/2022; 22/3/22: Stat Rep: RP-211871->RP-220153 20/6/22: WG: R4->R2; Rapporteur: ZTE->Eswar Vutukuri, ZTE Corporation; Rap eMail: ->es...; 9/1/23: 70%->100
- 1216: 9/9/22: Comp...; 9/12/22: FCD:23/12/2022->01/12/2023; Compl:15%->30%; Stat Rep: ->RP-223385; Rapporteur: Qualcomm->Yogesh Tugnawat, Qualcomm; Rap eMail: ->yogesht[at]qti.qualcomm.com; 17/3/23: FCD:30/11/2023->12/12/2023; Compl:30%->75%; S.....; 14/3/24: FCD:05/06/2024->06/06/2024; Compl:90%->95%; Stat Rep: RP-233874->RP-240293;
- 1217: affects: NR. no Perf. part; compare REL-16 WI NR_IIOT and NR_L1enh_URLLC; 7/4/21: WID:RP-201310->RP-210854; 5/4/22: WID:RP-210854->RP-220152
- 1218: affects: NR. no Perf. part; compare REL-16 WI NR_IIOT and NR_L1enh_URLLC; 28/7/20: WID:RP-193233->RP-201310; 13/9/21: Compl:0%->55% ; ; 20/6/22: Rapporteur: Nokia->Chunli Wu, Nokia; Rap eMail: ->Chunli.wu@nokia-sbell.com; 9/12/22: FCD:22/03/2022->...
- 1219: ; 13/9/21: CD:Tue 15/03/22->Wed 22/09/21; 13/9/21: Stat Rep: ->RP-211938; 22/3/22: CD:22/09/2021->12/09/2022; 22/3/22: Stat Rep: RP-211938->RP-220151 20/6/22: WG: R4->R2; Rapporteur: Nokia->Chunli Wu, Nokia; Rap eMail: ->Chunli.wu@nokia-sbell.com; ...; 9/12/22: FCD:22/12/2022->01/12/2022; Compl:85%->100%; Stat Rep: RP-221198->RP-223027;
- 1220: 9/9/22: Comp...; 9/12/22: FCD:23/06/2023->01/06/2023; Stat Rep: ->RP-223013; Rapporteur: Nokia->Matti Kangas, Nokia, Nokia Shanghai Bell; Rap eMail: ->matti.kangas@nokia.com; 31/3/23: Compl:5%->74%; Stat Rep: RP-223013->RP-230700; ;...; 6/9...; 8/12/23: Compl:82%->100%; Stat Rep: RP-231544->RP-232885;
- 1221: -
- 1222: affects: NR. compare REL-16 WI 5G_V2X_NRSL; 28/7/20: WID:RP-193257->RP-201385; 25/9/20: WID:RP-201385->RP-201516; 6/1/21: WID:RP-201516->RP-202846
- 1223: affects: NR. compare REL-16 WI 5G_V2X_NRSL; 13/9/21: Compl:0%->63%; ;
- 1224: affects: NR.; 13/9/21: CD:Wed 15/12/21->Wed 22/09/21; ; 22/3/22: Compl:0%->10%; 22/3/22: CD:22/09/2021->12/09/2022 20/6/22: FCD:12/09/2022->22/09/2022; Compl:10%->95%; Stat Rep: RP-220520->RP-221186; Rapporteur: LG Electronics->Seungmin Lee, LG El...; 23/9/22: 100%->100
- 1225: 9/9/22: Comp...; 9/12/22: FCD:23/09/2022->01/09/2023; Stat Rep: ->RP-223140; Rapporteur: CATT->Xiaozhong CHEN, CATT; Rap eMail: ->chenxiaozhong@catt.cn; 17/3/23: FCD:09/09/2023->08/09/2023; Stat Rep: RP-223140->RP-230396; ...; 6/9/23: FCD:0...; 2/4/24: WID:RP-221448->RP-240389
- 1226: affects: NR. TR 38.8xx; 25/9/20: WID:RP-193253->RP-201474; 6/1/21: WID:RP-201474->RP-202208; 7/4/21: 0%->100
- 1227: 13/9/19: 0%->25; 8/10/19: 23.764 added;; 6/12/19: 25%->35; 25/3/20: WID:SP-190477->SP-200110; 25/3/20: FCD:12/03/2020->06/20; 26/3/20: 35%->50; 28/6/20: 50%->75; 13/9/20: 75%->95; 22/3/22: 95%->100 / Impacted TSs and TRs: 23.764

| ID | WBS | Task | Type | Duration | Start | Finish | Complete | Remaining | Total slack | Constraint | Resources | Work | Actual work | Acronym | PCG approved | Impacted TSs and TRs | WI rapporteur name | WI rapporteur e-mail | Release | TSG approved | Status Report |
| --- | --- | --- | --- | --- | --- | --- | --- | --- | --- | --- | --- | --- | --- | --- | --- | --- | --- | --- | --- | --- | --- |
| 1228 | 605 | **Enhanced application layer support for V2X services** |  | 389d | 2020-09-16 A | 2022-03-11 A | 100% |  |  |  |  | 7728h | 7728h | eV2XAPP | 45 | 23.286; 23.434 | Niranth Amogh, Huawei Telecommunications India | namogh@huawei.com | Rel-17 | 89 |  |
| 1229 | 605.1 | Stage 2 of eV2XAPP |  | 195d | 2020-09-16 A | 2021-06-15 A | 100% |  |  | finish no earlier than 2021-06-15 | S6 | 1560h | 1560h | eV2XAPP | 45 | 23.286; 23.434 | Niranth Amogh, Huawei Telecommunications India | namogh@huawei.com | Rel-17 | 89 |  |
| 1230 | 605.2 | **CT aspects of eV2XAPP** |  | 258d | 2021-03-18 A | 2022-03-11 A | 100% |  |  |  | ct | 6168h | 6168h | eV2XAPP | 46 | 24.486; 24.544; 24.545; 24.546; 24.547; 24.548; 29.549 | Herrero Veron, Christian (Huawei) |  | Rel-17 | 91 |  |
| 1231 | 605.2.1 | CT1 aspects of eV2XAPP |  | 257d | 2021-03-18 A | 2022-03-11 A | 100% |  |  | finish no earlier than 2022-03-12 | C1 | 2056h | 2056h | eV2XAPP | 46 |  | Herrero Veron, Christian (Huawei) |  | Rel-17 | 91 |  |
| 1232 | 605.2.2 | CT3 aspects of eV2XAPP |  | 257d | 2021-03-18 A | 2022-03-11 A | 100% |  |  | finish no earlier than 2022-03-12 | C3 | 2056h | 2056h | eV2XAPP | 46 |  | Herrero Veron, Christian (Huawei) |  | Rel-17 | 91 |  |
| 1233 | 606 | **Support of advanced V2X services - Phase 2** |  | 648d | 2019-09-19 A | 2022-03-11 A | 100% |  |  |  |  | 8800h | 8800h | eV2XARC_Ph2 | 46 | 23.287 | LaeYoung Kim, LG Electronics | laeyoung.kim@lge.com | Rel-17 | 91 |  |
| 1234 | 606.1 | Study on V2X services – Phase 2 |  | 387d | 2019-09-19 A | 2021-03-12 A | 100% |  |  | finish no earlier than 2021-03-12 | S2 | 3096h | 3096h | FS_eV2XARC_Ph2 | 43 | New | LaeYoung Kim, LG Electronics | laeyoung.kim@lge.com | Rel-17 | 85 |  |
| 1235 | 606.2 | Stage 2 of eV2XARC_Ph2 |  | 125d | 2021-03-18 A | 2021-09-08 A | 100% |  |  | finish no earlier than 2021-09-08 | S2 | 1000h | 1000h | eV2XARC_Ph2 | 46 | 23.287 | LaeYoung Kim, LG Electronics | laeyoung.kim@lge.com | Rel-17 | 91 |  |
| 1236 | 606.3 | CT1 aspects of eV2XARC_Ph2 |  | 196d | 2021-06-11 A | 2022-03-11 A | 100% |  |  | finish no earlier than 2022-03-12 | C1 | 1568h | 1568h | eV2XARC_Ph2 | 47 | 24.588;24.587 | Herrero Veron, Christian (Huawei) | Christian.Herrero at huawei.com | Rel-17 | 92 |  |
| 1237 | 606.4 | Deleted- CT3 aspects of eV2XARC_Ph2 |  | 196d | 2021-06-11 A | 2022-03-11 A | 100% |  |  | finish no earlier than 2022-03-12 | C3 | 1568h | 1568h | eV2XARC_Ph2 | 47 | 31.102;29.522;29.525;29.519 | Herrero Veron, Christian (Huawei) | Christian.Herrero at huawei.com | Rel-17 | 92 |  |
| 1238 | 606.5 | CT6 aspects of eV2XARC_Ph2 |  | 196d | 2021-06-11 A | 2022-03-11 A | 100% |  |  | finish no earlier than 2022-03-12 | C6 | 1568h | 1568h | eV2XARC_Ph2 | 47 | 31.102 | Herrero Veron, Christian (Huawei) | Christian.Herrero at huawei.com | Rel-17 | 92 |  |
| 1239 | 607 | Rel-17 NR enhancements | milestone, manual | 0d | 2016-06-09 A | 2016-06-09 A | 100% |  |  |  |  |  |  |  |  | 26.234; 26.247 |  |  | Rel-17 |  |  |
| 1240 | 608 | **UE RF requirements for Transparent Tx Diversity (TxD) for NR** |  | 596d | 2021-06-15 A | 2023-09-22 | 99% | 0d | 0d |  | R4 | 10936h | 7224h | NR_RF_TxD | 47 |  | Qualcomm |  | Rel-17 | 92 |  |
| 1241 | 608.1 | Core part: UE RF requirements for Transparent Tx Diversity (TxD) for NR |  | 194d | 2021-06-15 A | 2022-03-11 A | 100% |  |  | finish no earlier than 2022-03-22 | R4 | 1552h | 1552h | NR_RF_TxD-Core | 47 | 38.837 | Qualcomm |  | Rel-17 | 92 | RP-220467 |
| 1242 | 608.2 | Perf. part: UE RF requirements for Transparent Tx Diversity (TxD) for NR |  | 194d | 2021-06-15 A | 2022-03-11 A | 100% |  |  | finish no earlier than 2022-03-22 | R4 | 1552h | 1552h | NR_RF_TxD-Perf | 47 |  | Qualcomm |  | Rel-17 | 92 | RP-220467 |
| 1243 | 608.3 | UE Conformance - UE RF requirements for Transparent Tx Diversity (TxD) for NR |  | 466d | 2021-12-13 A | 2023-09-22 A | 100% |  |  | finish no earlier than 2023-09-22 | R5 | 3728h | 3728h | NR_RF_TxD-UEConTest | 48 |  | Yaping ZHANG, Huawei | zhangyaping13@huawei.com | Rel-17 | 94 | RP-232351 |
| 1244 | 609 | **Further enhancements on MIMO for NR** |  | 1173d | 2019-12-16 A | 2024-06-06 | 91% | 106.72d | 453d |  |  | 15088h | 10928h | NR_feMIMO | 44 |  | Samsung |  | Rel-17 | 86 |  |
| 1245 | 609.1 | Core part: Further enhancements on MIMO for NR |  | 592d | 2019-12-16 A | 2022-03-22 A | 100% |  |  | finish no earlier than 2022-03-22 | R1 | 4736h | 4736h | NR_FeMIMO-Core | 44 |  | Eko Onggosanusi, Samsung | eko.o@samsung.com | Rel-17 | 86 | RP-221403 |
| 1246 | 609.2 | Perf. part: Further enhancements on MIMO for NR |  | 774d | 2019-12-16 A | 2022-12-01 A | 100% |  |  | finish no earlier than 2022-12-01 | R1 | 6192h | 6192h | NR_feMIMO-Perf | 44 |  | Eko Onggosanusi, Samsung | eko.o@samsung.com | Rel-17 | 86 | RP-222928 |
| 1247 | 609.3 | UE Conformance - Further enhancements on MIMO for NR |  | 520d | 2022-06-15 A | 2024-06-06 | 67% | 171.6d | 453d | finish no earlier than 2024-06-06 | R5 | 4160h |  | NR_feMIMO-UEConTest | 49 |  | Runsen Tang, Samsung | runsen.tang@samsung.com | Rel-17 | 96 | RP-240369 |
| 1248 | 610 | **NR Dynamic spectrum sharing (DSS)** |  | 593d | 2019-12-16 A | 2022-03-22 A | 100% |  |  |  |  | 4736h | 4736h | NR_DSS | 44 |  | Ericsson |  | Rel-17 | 86 |  |
| 1249 | 610.1 | Core part: NR DSS |  | 592d | 2019-12-16 A | 2022-03-22 A | 100% |  |  | finish no earlier than 2022-03-22 | R1 | 4736h | 4736h | NR_DSS-Core | 44 |  | Ravikiran Nory | ravikiran.nory@ericsson.com | Rel-17 | 86 | RP-220463 |
| 1250 | 611 | **UE power saving enhancements for NR** |  | 1102d | 2019-12-16 A | 2024-03-01 A | 100% |  |  |  |  | 19232h | 19232h | NR_UE_pow_sav_enh | 44 |  | MediaTek |  | Rel-17 | 86 |  |
| 1251 | 611.1 | Core part: UE power saving enhancements for NR |  | 592d | 2019-12-16 A | 2022-03-22 A | 100% |  |  | finish no earlier than 2022-03-22 | R2 | 4736h | 4736h | NR_UE_pow_sav_enh-Core | 44 |  | Weide Wu / Dapeng Li | weide.wu@mediatek.com / dapeng@zte.com.cn | Rel-17 | 86 | RP-221542 |
| 1252 | 611.2 | Perf. part: UE power saving enhancements for NR |  | 724d | 2019-12-16 A | 2022-09-22 A | 100% |  |  | finish no earlier than 2022-09-22 | R2 | 5792h | 5792h | NR_UE_pow_sav_enh-Perf | 44 |  | Weide Wu / Dapeng Li | weide.wu@mediatek.com / dapeng@zte.com.cn | Rel-17 | 86 | RP-221542 |
| 1253 | 611.3 | UE Conformance Test Aspects -UE Power Saving in NR |  | 639d | 2020-06-22 A | 2022-12-01 A | 100% |  |  | finish no earlier than 2022-12-01 | R5 | 5112h | 5112h | NR_UE_pow_sav-UEConTest | 45 |  | Huiying ZHANG, CATT | zhanghuiying@catt.cn | Rel-16 | 88 | RP-223138 |
| 1254 | 611.4 | UE Conformance - UE power saving enhancements for NR |  | 449d | 2022-06-15 A | 2024-03-01 A | 100% |  |  | finish no earlier than 2024-03-01 | R5 | 3592h | 3592h | NR_UE_pow_sav_enh_plus_CT-UEConTest | 49 |  | Eniko Sokondar, Vijay Balasubramanian, MediaTek, Qualcomm | eniko.sokondar[at]mediatek.com, vijayb[at]qti.qualcomm.com | Rel-17 | 96 | RP-233246 |

Notes:
- 1228: ; 5/12/20: 0%->35; 10/2/21: FCD:12/03/2021->06/21
- 1229: ; 5/12/20: 0%->35; 10/2/21: FCD:12/03/2021->06/21; 21/3/21: 35%->55; 11/6/21: 55%->100
- 1230: ; 11/6/21: WID:CP-210273->CP-211109
- 1231: ; 11/6/21: 0%->35; 13/9/21: 35%->65; 13/12/21: 65%->85; 12/3/22: 85%->100
- 1232: ; 11/6/21: 0%->50; 13/12/21: 50%->90; 12/3/22: 90%->100
- 1234: ; 26/6/20: FCD:12/06/2020->09/20; 26/6/20: 0%->25; 12/9/20: 25%->70; 12/9/20: FCD:15/09/2020->12/20; 5/12/20: 70%->86; 5/12/20: FCD:15/12/2020->03/20; 19/3/21: 86%->100
- 1235: ; 14/6/21: 0%->70; 14/6/21: FCD:Fri 11/06/->09/21; 13/9/21: 70%->95; 10/12/21: 95%->100
- 1236: ; 13/9/21: 0%->45; 13/12/21: 45%->90; 12/3/22: 90%->100
- 1237: 03/22: No task for CT3; 22/3/22: 0%->100
- 1238: ; 4/6/22: 0%->100
- 1240: TR38.8xx; impact on REL-15/16? ; 29/9/21: WID:RP-211597->RP-211940
- 1241: TR38.8xx; impact on REL-15/16? ; 13/9/21: Compl:0%->50%; 13/9/21: CD:Tue 15/03/22->Tue 22/03/22 ; 1/10/21: 38.837 added ;
- 1242: ; 13/9/21: Compl:0%->10%; 13/9/21: CD:Tue 15/03/22->Tue 22/03/22 ; ;
- 1243: tested: REL-17 WI NR_RF_TxD; 22/3/22: Compl:0%->5%; 22/3/22: Stat Rep: ->RP-220420 6/6/22: Compl:5%->23% 20/6/22: Rapporteur: Huawei->Chunying GU, Huawei; Rap eMail: ->guchunying@huawei.com12/7/22: WID:RP-213229->RP-221491 ...; 9/12/22: FCD:22/12/202...; 6/9/23: FCD:09/09/2023->22/09/2023; Compl:99%->100%; WID: RP-213229->RP-231240; Stat Rep: RP-230432->RP-232351; Rapporteur: Yaping Zhang, Huawei->Yaping ZHANG, Huawei;
- 1244: affects: NR. compare REL-16 WI NR_eMIMO; 25/9/20: WID:RP-193133->RP-202024; 2/7/21: WID:RP-202024->RP-211586; 29/9/21: WID:RP-211586->RP-212535
- 1245: affects: NR. compare REL-16 WI NR_eMIMO; 13/9/21: Compl:0%->70%; 13/9/21: CD:Tue 15/06/21->Tue 22/03/22; 13/9/21: Stat Rep: ->RP-211788 ; 20/6/22: Acronym:NR_feMIMO-Core->NR_FeMIMO-Core; Rapporteur: Samsung->Eko Onggosanusi, Samsung; Rap eMail: ...
- 1246: affects: NR.; 13/9/21: CD:Wed 15/12/21->Wed 22/09/21; 13/9/21: Stat Rep: ->RP-211788; 22/3/22: Compl:0%->25%; 20/6/22: Acronym:NR_feMIMO-Perf->NR_FeMIMO-Perf; WG: R4->R1; Rapporteur: Samsung->Eko Onggosanusi, Samsung; Rap eMail: ->eko.o@samsung.c...;...; 9/1/23: 100%->100; Acronym reverted to NR_feMIMO-Perf
- 1247: 9/9/22: Comp...; 9/12/22: FCD:23/12/2022->01/12/2023; Stat Rep: ->R5-226804; Rapporteur: Samsung->Runsen Tang, Samsung; Rap eMail: ->runsen.tang@samsung.com; 17/3/23: FCD:30/11/2023->12/12/2023; Compl:5%->10%; Stat Rep: R5-226804->RP-2301.....; 14/3/24: FCD:05/06/2024->06/06/2024; Stat Rep: RP-233142->RP-240369;
- 1248: affects: NR. no Perf. part; 2/7/21: WID:RP-193260->RP-211345
- 1249: affects: NR. no Perf. part; 20/6/22: FCD:15/03/2021->22/03/2022; Compl:0%->100%; Stat Rep: ->RP-220463; Rapporteur: Ericsson->Ravikiran Nory; Rap eMail: ->ravikiran.nory@ericsson.com;
- 1250: affects: NR. compare REL-16 WI NR_UE_pow_sav; 26/3/20: WID:RP-193239->RP-200494; 30/6/20: WID:RP-200494->RP-193239; 28/7/20: WID:RP-193239->RP-200938; 29/9/21: WID:RP-200938->RP-212630; 5/4/22: WID:RP-212630->RP-220748; 12/7/22: WID:RP-220748->RP-221543
- 1251: affects: NR. compare REL-16 WI NR_UE_pow_sav; ; 20/6/22: FCD:11/03/2022->22/03/2023; Stat Rep: RP-220747->RP-221542; Rapporteur: MediaTek->Weide Wu / Dapeng Li; Rap eMail: ->weide.wu@mediatek.com / dapeng@zte.com.cn;
- 1252: affects: NR.; ; 20/6/22: WG: R4->R2; FCD:12/09/2022->22/09/2022; Compl:35%->65%; Stat Rep: RP-220747->RP-221542; Rapporteur: MediaTek->Weide Wu / Dapeng Li; Rap eMail: ->weide.wu@mediatek.com / dapeng@zte.com.cn9/9/22: 65%->100; 23/9/22: 100%->100
- 1253: 8/10/20: 0%->5; 6/1/21: WID:RP-200930->RP-202726; 8/4/21: 5%->39; 2/7/21: FCD:Mon 21/06/->09/21; 2/7/21: 39%->52; 6/1/22: WID:RP-202726->RP-213291; 20/6/22: Rapporteur: CATT->Huiying ZHANG, CATT; Rap eMail: ->zhanghuiying@catt.cn ; ...; 9/12/22: FCD...; 9/1/23: 100%->100
- 1254: 9/9/22: Comp...; 9/12/22: FCD:23/12/2022->01/12/2023; Compl:3%->20%; Stat Rep: ->RP-223228; Rapporteur: MediaTek->Eniko Sokondar, Vijay Balasubramanian, MediaTek, Qualcomm; Rap eMail: ->eniko.sokondar[at]mediatek.com, vijayb[at]qti.qualcomm...; 2/4/24: 97%->100

| ID | WBS | Task | Duration | Start | Finish | Complete | Remaining | Total slack | Constraint | Resources | Work | Actual work | Acronym | PCG approved | Release | TSG approved | Status Report | Impacted TSs and TRs |
| --- | --- | --- | --- | --- | --- | --- | --- | --- | --- | --- | --- | --- | --- | --- | --- | --- | --- | --- |
| 1255 | 612 | **Further Multi-RAT Dual-Connectivity enhancements** | 1173d | 2019-12-16 A | 2024-06-06 | 99% | 14.27d | 453d |  |  | 13136h | 10472h | LTE_NR_DC_enh2 | 44 | Rel-17 | 86 |  |  |
| 1256 | 612.1 | Core part: Further Multi-RAT Dual-Connectivity enhancements | 585d | 2019-12-16 A | 2022-03-11 A | 100% |  |  | finish no earlier than 2022-03-12 | R2 | 4680h | 4680h | LTE_NR_DC_enh2-Core | 44 | Rel-17 | 86 | RP-220409 |  |
| 1257 | 612.2 | Perf. part: Further Multi-RAT Dual-Connectivity enhancements | 724d | 2019-12-16 A | 2022-09-22 A | 100% |  |  | finish no earlier than 2022-09-22 | R4 | 5792h | 5792h | LTE_NR_DC_enh2-Perf | 44 | Rel-17 | 86 | RP-220409 |  |
| 1258 | 612.3 | UE Conformance - Further Multi-RAT Dual-Connectivity enhancement | 333d | 2023-03-03 A | 2024-06-06 | 94% | 19.98d | 453d | finish no earlier than 2024-06-06 | R5 | 2664h |  | LTE_NR_DC_enh2-UEConTest | 50 | Rel-17 | 99 | RP-240281 |  |
| 1259 | 613 | **Enhancements to Integrated Access and Backhaul (IAB) for NR** | 925d | 2019-03-11 A | 2022-09-22 A | 100% |  |  |  |  | 16816h | 16816h | NR_IAB_enh | 44 | Rel-17 | 86 |  |  |
| 1260 | 613.1 | Core part: Enhancements to IAB for NR | 658d | 2019-12-16 A | 2022-06-22 A | 100% |  |  | finish no earlier than 2022-06-22 | R2 | 5264h | 5264h | NR_IAB_enh-Core | 44 | Rel-17 | 86 | RP-221176 |  |
| 1261 | 613.2 | Perf. part: Enhancements to IAB for NR | 724d | 2019-12-16 A | 2022-09-22 A | 100% |  |  | finish no earlier than 2022-09-22 | R2 | 5792h | 5792h | NR_IAB_enh-Perf | 44 | Rel-17 | 86 | RP-221176 |  |
| 1262 | 613.3 | Study on Security for NR_IAB | 720d | 2019-03-11 A | 2021-12-10 A | 100% |  |  | finish no earlier than 2021-12-12 | S3 | 5760h | 5760h | FS_NR_IAB_Sec | 42 | Rel-17 | 83 |  | 33.824 |
| 1263 | 614 | **Enhanced eNB(s) architecture evolution for E-UTRAN and NG-RAN** | 584d | 2019-12-16 A | 2022-03-09 A | 100% |  |  |  |  | 4664h | 4664h | LTE_NR_arch_evo_enh | 44 | Rel-17 | 86 |  | 37.483; 37.482; 37.481; 37.480; 37.480; |
| 1264 | 614.1 | Core part: LTE_NR_arch_evo_enh | 583d | 2019-12-16 A | 2022-03-09 A | 100% |  |  | finish no earlier than 2022-03-09 | R3 | 4664h | 4664h | LTE_NR_arch_evo_enh-Core | 44 | Rel-17 | 86 | RP-220557 |  |
| 1265 | 615 | **Further enhancement on NR demodulation performance** | 977d | 2020-09-15 A | 2024-06-06 | 92% | 77.16d | 453d |  |  | 9480h | 5320h | NR_demod_enh2 | 45 | Rel-17 | 89 |  |  |
| 1266 | 615.1 | Core part: Further enhancement on NR demodulation performance | 137d | 2021-12-14 A | 2022-06-22 A | 100% |  |  | finish no earlier than 2022-06-22 | R4 | 1096h | 1096h | NR_demod_enh2-Core | 48 | Rel-17 | 94 | RP-221284 |  |
| 1267 | 615.2 | Perf. part: NR_demod_enh2 | 528d | 2020-09-15 A | 2022-09-22 A | 100% |  |  | finish no earlier than 2022-09-22 | R4 | 4224h | 4224h | NR_demod_enh2-Perf | 45 | Rel-17 | 89 | RP-221284 | 38.833 |
| 1268 | 615.3 | UE Conformance - Further enhancement on NR demodulation performance | 520d | 2022-06-15 A | 2024-06-06 | 82% | 93.6d | 453d | finish no earlier than 2024-06-06 | R5 | 4160h |  | NR_demod_enh2-UEConTest | 49 | Rel-17 | 96 | RP-240344 |  |
| 1269 | 616 | **Introduction of DL 1024QAM for NR frequency range 1 (FR1)** | 848d | 2020-09-15 A | 2023-12-12 A | 100% |  |  |  |  | 9992h | 9992h | NR_DL1024QAM_FR1 | 45 | Rel-17 | 89 |  |  |
| 1270 | 616.1 | Core part: Introduction of DL 1024QAM for NR FR1 | 396d | 2020-09-15 A | 2022-03-22 A | 100% |  |  | finish no earlier than 2022-03-22 | R4 | 3168h | 3168h | NR_DL1024QAM_FR1-Core | 45 | Rel-17 | 89 | RP-220190 |  |
| 1271 | 616.2 | Perf. part: Introduction of DL 1024QAM for NR FR1 | 462d | 2020-09-15 A | 2022-06-22 A | 100% |  |  | finish no earlier than 2022-06-22 | R4 | 3696h | 3696h | NR_DL1024QAM_FR1-Perf | 45 | Rel-17 | 89 | RP-221226 /1771 |  |
| 1272 | 616.3 | UE Conformance - Introduction of DL 1024QAM for NR FR1 | 391d | 2022-06-15 A | 2023-12-12 A | 100% |  |  | finish no earlier than 2023-12-12 | R5 | 3128h | 3128h | NR_DL1024QAM_FR1-UEConTest | 49 | Rel-17 | 96 | RP-233873 |  |
| 1273 | 617 | **NR RRM further enhancement** | 529d | 2020-09-15 A | 2022-09-22 A | 100% |  |  |  |  | 7392h | 7392h | NR_RRM_enh2 | 45 | Rel-17 | 89 |  |  |
| 1274 | 617.1 | Core part: Further RRM enhancement for NR and MR-DC | 396d | 2020-09-15 A | 2022-03-22 A | 100% |  |  | finish no earlier than 2022-03-22 | R4 | 3168h | 3168h | NR_RRM_enh2-Core | 45 | Rel-17 | 89 | RP-221699 |  |
| 1275 | 617.2 | Perf. part: Further RRM enhancement for NR and MR-DC | 528d | 2020-09-15 A | 2022-09-22 A | 100% |  |  | finish no earlier than 2023-03-22 | R4 | 4224h | 4224h | NR_RRM_enh2-Perf | 45 | Rel-17 | 89 | RP-221699 |  |
| 1276 | 618 | **Enhanced NR support for high speed train scenario for frequency range 1 (FR1)** | 712d | 2020-09-15 A | 2023-06-06 A | 100% |  |  |  |  | 9432h | 9432h | NR_HST_FR1_enh | 45 | Rel-17 | 89 |  |  |
| 1277 | 618.1 | Core part: Enhanced NR support for high speed train scenario for FR1 | 396d | 2020-09-15 A | 2022-03-22 A | 100% |  |  | finish no earlier than 2022-03-22 | R4 | 3168h | 3168h | NR_HST_FR1_enh-Core | 45 | Rel-17 | 89 | RP-221353 |  |
| 1278 | 618.2 | Perf. part: Enhanced NR support for high speed train scenario for FR1 | 528d | 2020-09-15 A | 2022-09-22 A | 100% |  |  | finish no earlier than 2022-09-22 | R4 | 4224h | 4224h | NR_HST_FR1_enh-Perf | 45 | Rel-17 | 89 | RP-221353 |  |
| 1279 | 618.3 | UE Conformance - Enhanced NR support for high speed train scenario for frequency range 1 (FR1) | 255d | 2022-06-15 A | 2023-06-06 A | 100% |  |  | finish no earlier than 2023-06-06 | R5 | 2040h | 2040h | NR_HST_FR1_enh-UEConTest | 49 | Rel-17 | 96 | RP-230283 |  |

Notes:
- 1255: affects: LTE, NR. compare REL-16 WI LTE_NR_DC_CA_enh; 28/7/20: WID:RP-193249->RP-201040 / WI rapporteur name: Huawei
- 1256: affects: LTE, NR. compare REL-16 WI LTE_NR_DC_CA_enh; / WI rapporteur name: Huawei
- 1257: affects: LTE, NR.; 22/3/22: CD:15/12/2021->12/09/2022; 22/3/22: Stat Rep: ->RP-220409; 20/6/22: WG: R4->R2; FCD:12/09/2022->22/09/2022; Compl:0%->30%; Stat Rep: RP-220409->RP-221500; Rapporteur: Huawei->David Lecompte, Huawei; Rap eMail: ->david.lecomp...9/9/22: Compl:30%->100%9/9/22: CD:12/09/2022->22/09/2022 / WI rapporteur name: Matti Kangas / WI rapporteur e-mail: matti.kangas@nokia.com
- 1258: ; 7/6/23: Compl:0%->5%; 6/9/23: Compl:5%->46%; Stat Rep: ->RP-232355; Rapporteur: Huawei->Yaping ZHANG, Huawei; Rap eMail: ->zhangyaping13@huawei.com; ; 8/12/23: FCD:03/03/2024->01/03/2024; Compl:46%->94%; Stat Rep: RP-232355->RP-233763; ; 2/1/24: WID...; 14/3/24: FCD:01/03/2024->06/06/2024; WID: RP-233764->RP-230436; Stat Rep: RP-233763->RP-240281; / WI rapporteur name: Yaping ZHANG, Huawei / WI rapporteur e-mail: zhangyaping13@huawei.com
- 1259: affects: NR. compare REL-16 WI NR_IAB; 28/7/20: WID:RP-193251->RP-201293; 7/4/21: WID:RP-201293->RP-210758; 2/7/21: WID:RP-210758->RP-211548; 6/1/22: WID:RP-211548->RP-213668; 12/7/22: WID:RP-213668->RP-221177 / WI rapporteur name: Qualcomm
- 1260: affects: NR. compare REL-16 WI NR_IAB; 13/9/21: Compl:0%->41%; 13/9/21: CD:Tue 15/06/21->Tue 22/03/22; 13/9/21: Stat Rep: ->RP-211767 ; 20/6/22: Rapporteur: Qualcomm->Georg Hampel, Qualcomm Incorporated; Rap eMail: ->ghampel@qti.qualcomm.com; / WI rapporteur name: Georg Hampel, Qualcomm Incorporated / WI rapporteur e-mail: ghampel@qti.qualcomm.com
- 1261: affects: NR.; 13/9/21: CD:Wed 15/12/21->Wed 22/09/21; 13/9/21: Stat Rep: ->RP-211767; 22/3/22: Compl:0%->20%; 22/3/2 20/6/22: WG: R4->R2; Rapporteur: Qualcomm->Georg Hampel, Qualcomm Incorporated; Rap eMail: ->ghampel@qti.qualcomm.com9/9/22: ... / WI rapporteur name: Georg Hampel, Qualcomm Incorporated / WI rapporteur e-mail: ghampel@qti.qualcomm.com
- 1262: 31/5/19: 0%->20; 13/9/19: 20%->50; 13/9/19: FCD:09/09/2019->12/20; 26/6/20: FCD:12/12/2019->12/20; 12/9/20: 50%->75; 5/12/20: FCD:15/12/2020->03/20; 5/12/20: WID:SP-190106->SP-201016, Rel-16->17; 9/4/21: FCD:12/03/2021->06/21; 11/6/21: 75%->78; 11/6/21 / WI rapporteur name: Rajavelsamy Rajadurai, Samsung, / WI rapporteur e-mail: rajvel{@]samsung.com
- 1263: affects: LTE, NR. No Perf. Part; compare REL-16 WI LTE_NR_arch_evo; 2/7/21: WID:RP-193181->RP-211409; 6/1/22: WID:RP-211409->RP-213667; 7/1/22: 37.483 added;; 7/1/22: 37.480 added; / WI rapporteur name: China Unicom
- 1264: affects: LTE, NR. no Perf. part; compare REL-16 WI LTE_NR_arch_evo; 6/1/22: WID:RP-211409->RP-213667; 20/6/22: FCD:15/12/2020->22/03/2023; Compl:0%->100%; Stat Rep: ->RP-220557; Rapporteur: China Unicom->Gen Cao; Rap eMail: ->caogen@chinaunicom.cn2... / WI rapporteur name: Gen Cao / WI rapporteur e-mail: caogen@chinaunicom.cn
- 1265: demodulation aspects were introduced in REL-15 WI NR_newRAT and enhanced in REL-16 WI NR_perf_enh-Perf; no Core part ; 6/1/21: WID:RP-202000->RP-202828; 7/4/21: WID:RP-202828->RP-210920; 2/7/21: WID:RP-210920->RP-211135; 29/9/21: WID:RP-211135->RP-2126 ; 12/7/22: WID:RP-213656->RP-221285 / WI rapporteur name: China Telecom
- 1266: ; 20/6/22: Rapporteur: China Telecom->Shan YANG, Tricia LI, Dmitry BELOV, China Telecom, Huawei, Intel Corporation; Rap eMail: ->yangshan@chinatelecom.cn, tricia.li@huawei.com, dmitry.belov@intel.com; / WI rapporteur name: Shan YANG, Tricia LI, Dmitry BELOV, China Telecom, Huawei, Intel Corporation / WI rapporteur e-mail: yangshan@chinatelecom.cn, tricia.li@huawei.com, dmitry.belov@intel.com
- 1267: demodulation aspects were introduced in REL-15 WI NR_newRAT and enhanced in REL-16 WI NR_perf_enh-Perf; no Core part ; 2/7/21: 38.833 added;; 13/9/21: Compl:0%->45%; 13/9/21: C ; 6/1/22: WID:RP-212636->RP-213656 20/6/22: FCD:10/06/2022->22/09/2022;... / WI rapporteur name: Shan YANG, Tricia LI, Dmitry BELOV, China Telecom, Huawei, Intel Corporation / WI rapporteur e-mail: yangshan@chinatelecom.cn, tricia.li@huawei.com, dmitry.belov@intel.com
- 1268: 9/9/22: Comp...; 9/12/22: FCD:23/12/2022->01/12/2023; Stat Rep: ->RP-222947; Rapporteur: ChinaTelecom->Wu Jingzhou, Balasubramanian Vijay, China Telecom, Qualcomm Inc; Rap eMail: ->wujingzhou@chinatelecom.cn, vijayb@qti.qualcomm.com; 17/3.....; 14/3/24: FCD:05/06/2024->06/06/2024; Compl:65%->82%; WID: RP-233582->RP-233586; Stat Rep: RP-233583->RP-240344; / WI rapporteur name: Wu Jingzhou, Balasubramanian Vijay, China Telecom, Qualcomm Inc / WI rapporteur e-mail: wujingzhou@chinatelecom.cn, vijayb@qti.qualcomm.com
- 1269: ; 6/1/21: WID:RP-202044->RP-202886; 6/1/22: WID:RP-202886->RP-213654 / WI rapporteur name: Ericsson
- 1270: ; 20/6/22: FCD:08/09/2021->22/03/2022; Compl:0%->100%; Stat Rep: ->RP-220190; Rapporteur: Ericsson->Yi GUO; Rap eMail: ->yi.guo@intel.com; / WI rapporteur name: Yi GUO / WI rapporteur e-mail: yi.guo@intel.com
- 1271: ; 13/9/21: Compl:0%->90%; 13/9/21: CD:Sat 12/03/22->Tue 21/12/21; 13/9/21: Stat Rep: ->RP-211770; ; 20/6/22: FCD:11/03/2022->22/06/2022; Stat Rep: RP-220190->RP-221226 /1771; Rapporteur: Ericsson->Wanuga, Kevin (RAN1); Uesaka, Kazuyoshi (RAN4), Nokia, Ericsson; Rap eMail: ->kevin (dot) wanuga (at) nokia (dot) com; kazuyoshi (dot) uesaka (at) ericsson (dot) com; / WI rapporteur name: Wanuga, Kevin (RAN1); Uesaka, Kazuyoshi (RAN4), Nokia, Ericsson / WI rapporteur e-mail: kevin (dot) wanuga (at) nokia (dot) com; kazuyoshi (dot) uesaka (at) ericsson (dot) com
- 1272: 9/9/22: Comp...; 9/12/22: FCD:23/03/2023->01/03/2023; Compl:5%->34%; Stat Rep: ->RP-223384; Rapporteur: Qualcomm->Vijay Balasubramanian, Qualcomm; Rap eMail: ->vijayb[at]qti.qualcomm.com; 17/3/23: FCD:03/03/2023->08/09/2023; Stat Rep: RP-.....; 8/12/23: Compl:90%->100%; Stat Rep: RP-232015->RP-233873; / WI rapporteur name: Vijay Balasubramanian, Qualcomm / WI rapporteur e-mail: vijayb[at]qti.qualcomm.com
- 1273: LTE impacts? ; 6/1/21: WID:RP-202053->RP-202874; 6/1/22: WID:RP-202874->RP-213067 / WI rapporteur name: Apple
- 1274: LTE impacts? ; 4/6/22: 0%->100; 20/6/22: FCD:08/09/2021->22/03/2023; Stat Rep: ->RP-221699; Rapporteur: Apple->Jie Cui, Apple Corporation; Rap eMail: ->jie_cui@apple.com; / WI rapporteur name: Jie Cui, Apple Corporation / WI rapporteur e-mail: jie_cui@apple.com
- 1275: LTE impacts? ; 13/9/21: Compl:0%->60%; 13/9/21: CD:Sat 12/03/22->Tue 22/03/22 ; ; 20/6/22: FCD:22/03/2023->22/09/2022; Compl:100%->50%; Rapporteur: Apple->Jie Cui, Apple Corporation; Rap eMail: ->jie_cui@apple.com 9/9... / WI rapporteur name: Jie Cui, Apple Corporation / WI rapporteur e-mail: jie_cui@apple.com
- 1276: follow-up WI of REL-16 WI NR_HST ; 6/1/21: WID:RP-202106->RP-202335; 7/4/21: WID:RP-202335->RP-210833 / WI rapporteur name: CMCC
- 1277: follow-up WI of REL-16 WI NR_HST ; 13/9/21: Compl:0%->70%; 13/9/ ; ; 20/6/22: Rapporteur: CMCC->Jingjing Chen, CMCC; Rap eMail: ->chenjingjing@chinamobile.com; / WI rapporteur name: Jingjing Chen, CMCC / WI rapporteur e-mail: chenjingjing@chinamobile.com
- 1278: follow-up WI of REL-16 WI NR_HST ; 13/9/21: Compl:0%->50%; 1 ; 22/3/22: Compl:50%->70%; 20/6/22: Rapporteur: CMCC->Jingjing Chen, CMCC; Rap eMail: ->chenjingjing@chinamobile.com ; 9/9/22: Compl:85%->100% / WI rapporteur name: Jingjing Chen, CMCC / WI rapporteur e-mail: chenjingjing@chinamobile.com
- 1279: 9/9/22: Comp...; 9/12/22: FCD:23/06/2023->01/06/2023; Compl:23%->62%; Stat Rep: ->RP-223063; Rapporteur: CMCC->Dan SONG, CMCC; Rap eMail: ->songdan@chinamobile.com; 17/3/23: Compl:62%->71%; Stat Rep: RP-223063->RP-230283; ... / WI rapporteur name: Dan SONG, CMCC / WI rapporteur e-mail: songdan@chinamobile.com

| ID | WBS | Task | Type | Duration | Start | Finish | Complete | Remaining | Total slack | Constraint | Resources | Work | Actual work | Acronym | PCG approved | Impacted TSs and TRs | Release | TSG approved | WI rapporteur e-mail | Status Report |
| --- | --- | --- | --- | --- | --- | --- | --- | --- | --- | --- | --- | --- | --- | --- | --- | --- | --- | --- | --- | --- |
| 1280 | 619 | **Further enhancements of NR RF requirements for frequency range 2 (FR2)** |  | 906d | 2020-09-15 A | 2024-03-01 A | 100% |  |  |  |  | 11024h | 11024h | NR_RF_FR2_req_enh2 | 45 | 38.851 | Rel-17 | 89 |  |  |
| 1281 | 619.1 | Core part: NR_RF_FR2_req_enh2 |  | 462d | 2020-09-15 A | 2022-06-22 A | 100% |  |  | finish no earlier than 2022-06-22 | R4 | 3696h | 3696h | NR_RF_FR2_req_enh2-Core | 45 |  | Rel-17 | 89 | Petri.j.vasenkari@nokia.com | RP-221205 |
| 1282 | 619.2 | Perf. part: NR_RF_FR2_req_enh2 |  | 528d | 2020-09-15 A | 2022-09-22 A | 100% |  |  | finish no earlier than 2022-09-22 | R4 | 4224h | 4224h | NR_RF_FR2_req_enh2-Perf | 45 |  | Rel-17 | 89 | Petri.j.vasenkari@nokia.com | RP-221205 |
| 1283 | 619.3 | UE Conformance - Further enhancements of NR RF requirements for frequency range 2 (FR2) |  | 388d | 2022-09-08 A | 2024-03-01 A | 100% |  |  | finish no earlier than 2024-03-01 | R5 | 3104h | 3104h | NR_RF_FR2_req_enh2-UEConTest | 49 |  | Rel-17 | 97 | tuomo.saynajakangas@nokia.com ashwin_mohan@apple.com | RP-240092 |
| 1284 | 620 | **NR support for high speed train scenario in frequency range 2 (FR2)** |  | 977d | 2020-09-15 A | 2024-06-06 | 80% | 197.02d | 453d |  |  | 11552h | 7392h | NR_HST_FR2 | 45 |  | Rel-17 | 89 |  |  |
| 1285 | 620.1 | Core part: NR support for high speed train scenario in FR2 |  | 396d | 2020-09-15 A | 2022-03-22 A | 100% |  |  | finish no earlier than 2022-03-22 | R4 | 3168h | 3168h | NR_HST_FR2-Core | 45 |  | Rel-17 | 89 | h0809.wang@samsung.com | RP-221404 |
| 1286 | 620.2 | Perf. Part: NR support for high speed train scenario in FR2 |  | 528d | 2020-09-15 A | 2022-09-22 A | 100% |  |  | finish no earlier than 2022-09-22 | R4 | 4224h | 4224h | NR_HST_FR2-Perf | 45 |  | Rel-17 | 89 | h0809.wang@samsung.com | RP-221404 |
| 1287 | 620.3 | UE Conformance - NR support for high speed train scenario in frequency range 2 (FR2) |  | 520d | 2022-06-15 A | 2024-06-06 | 44% | 291.2d | 453d | finish no earlier than 2024-06-06 | R5 | 4160h |  | NR_HST_FR2-UEConTest | 49 |  | Rel-17 | 96 | runsen.tang@samsung.com | RP-240370 |
| 1288 | 621 | **NR measurement gap enhancements** |  | 529d | 2020-09-15 A | 2022-09-22 A | 100% |  |  |  |  | 7392h | 7392h | NR_MG_enh | 45 |  | Rel-17 | 89 |  |  |
| 1289 | 621.1 | Core part: NR and MR-DC measurement gap enhancements |  | 396d | 2020-09-15 A | 2022-03-22 A | 100% |  |  | finish no earlier than 2022-03-22 | R4 | 3168h | 3168h | NR_MG_enh-Core | 45 |  | Rel-17 | 89 | ato.yu@mediatek.com, rui.huang@intel.com | RP-221549 |
| 1290 | 621.2 | Perf. part: NR and MR-DC measurement gap enhancements |  | 528d | 2020-09-15 A | 2022-09-22 A | 100% |  |  | finish no earlier than 2023-03-22 | R4 | 4224h | 4224h | NR_MG_enh-Perf | 45 |  | Rel-17 | 89 | ato.yu@mediatek.com, rui.huang@intel.com | RP-221549 |
| 1291 | 622 | **RF requirements enhancement for NR frequency range 1 (FR1)** |  | 906d | 2020-09-15 A | 2024-03-01 A | 100% |  |  |  |  | 10984h | 10984h | NR_RF_FR1_enh | 45 |  | Rel-17 | 89 |  |  |
| 1292 | 622.1 | Core part: RF requirements enhancement for NR FR1 |  | 396d | 2020-09-15 A | 2022-03-22 A | 100% |  |  | finish no earlier than 2022-03-22 | R4 | 3168h | 3168h | NR_RF_FR1_enh-Core | 45 |  | Rel-17 | 89 | leo.liuye@huawei.com | RP-221501 |
| 1293 | 622.2 | Perf. part: RF requirements enhancement for NR FR1 |  | 528d | 2020-09-15 A | 2022-09-22 A | 100% |  |  | finish no earlier than 2022-09-22 | R4 | 4224h | 4224h | NR_RF_FR1_enh-Perf | 45 |  | Rel-17 | 89 | leo.liuye@huawei.com | RP-221501 |
| 1294 | 622.3 | UE Conformance - RF requirements enhancement for NR frequency range 1 (FR1) |  | 449d | 2022-06-15 A | 2024-03-01 A | 100% |  |  | finish no earlier than 2024-03-01 | R5 | 3592h | 3592h | NR_RF_FR1_enh-UEConTest | 49 |  | Rel-17 | 96 | guchunying@huawei.com | RP-240280 |
| 1295 | 623 | **4Rx support for NR band n8** |  | 204d | 2021-12-13 A | 2022-09-22 A | 100% |  |  |  | R4 | 3248h | 3248h | NR_4Rx_Bn8_FWA | 48 |  | Rel-17 | 94 |  |  |
| 1296 | 623.1 | Core part: 4Rx support for NR band n8 |  | 65d | 2021-12-13 A | 2022-03-11 A | 100% |  |  | start no earlier than 2021-12-12 | R4 | 520h | 520h | NR_4Rx_Bn8_FWA-Core | 48 |  | Rel-17 | 94 |  | RP-220394 |
| 1297 | 623.2 | Perf. part: 4Rx support for NR band n8 |  | 65d | 2021-12-13 A | 2022-03-11 A | 100% |  |  | start no earlier than 2021-12-12 | R4 | 520h | 520h | NR_4Rx_Bn8_FWA-Perf | 48 |  | Rel-17 | 94 |  | RP-220394 |
| 1298 | 623.3 | UE Conformance - 4Rx support for NR band n8 |  | 72d | 2022-06-15 A | 2022-09-22 A | 100% |  |  | finish no earlier than 2022-09-22 | R5 | 576h | 576h | NR_4Rx_Bn8_FWA-UEConTest | 49 |  | Rel-17 | 96 |  |  |
| 1299 | 624 | Rel-17 Self-Organizing (SON)/Autonomous Networks | milestone, manual | 0d | 2016-06-09 A | 2016-06-09 A | 100% |  |  | finish no earlier than 2016-06-09 |  |  |  |  |  | 26.234; 26.247 | Rel-17 |  |  |  |
| 1300 | 625 | **Enhancement of data collection for SON (Self-Organising Networks)/MDT (Minimization of Drive Tests) in NR and EN-DC** |  | 593d | 2019-12-16 A | 2022-03-22 A | 100% |  |  |  |  | 4736h | 4736h | NR_ENDC_SON_MDT_enh | 44 |  | Rel-17 | 86 |  |  |
| 1301 | 625.1 | Core part: Enhancement of data collection for SON (Self-Organising Networks)/MDT (Minimization of Drive Tests) in NR standalone and MR-DC (Multi-Radio Dual Connectivity) |  | 592d | 2019-12-16 A | 2022-03-22 A | 100% |  |  | finish no earlier than 2022-03-22 | R3 | 4736h | 4736h | NR_ENDC_SON_MDT_enh-Core | 44 |  | Rel-17 | 86 | liuliang@chinamobile.com, angelo.centonza@ericsson.com | RP-220820 |
| 1302 | 626 | Plug and connect support for management of Network Functions |  | 257d | 2021-03-18 A | 2022-03-11 A | 100% |  |  | finish no earlier than 2022-03-12 | S5 | 2056h | 2056h | PACMAN | 46 | 28.313 | Rel-17 | 91 | Per.elmdahl@ericsson.com |  |
| 1303 | 627 | Enhancements of Self-Organizing Networks (SON) for 5G networks |  | 513d | 2020-03-25 A | 2022-03-11 A | 100% |  |  | finish no earlier than 2022-03-12 | S5 | 4104h | 4104h | eSON_5G | 44 | 28.313; 28.552; 28.541; 28.545 | Rel-17 | 87 | joey<dot>chou<at>intel<dot>com |  |
| 1304 | 628 | Study on autonomous network levels |  | 258d | 2019-09-19 A | 2020-09-14 A | 100% |  |  | finish no earlier than 2020-09-14 | S5 | 2064h | 2064h | FS_ANL | 43 | New ; 28.810 | Rel-17 | 85 | caoxi@chinamobile.com |  |
| 1305 | 629 | Autonomous network levels |  | 391d | 2020-06-12 A | 2021-12-10 A | 100% |  |  | finish no earlier than 2021-12-12 | S5 | 3128h | 3128h | ANL | 45 |  | Rel-17 | 88 | caoxi@chinamobile.com |  |
| 1306 | 630 | Rel-17 Multicast-broadcast Services (MBS) and Mission Critical (MC) | milestone, manual | 0d | 2016-06-09 A | 2016-06-09 A | 100% |  |  | finish no earlier than 2016-06-09 |  |  |  |  |  | 26.234; 26.247 | Rel-17 |  |  |  |
| 1307 | 631 | Study on Multicast Architecture Enhancements for 5G Media Streaming |  | 318d | 2020-03-25 A | 2021-06-11 A | 100% |  |  | finish no earlier than 2021-06-12 | S4 | 2544h | 2544h | FS_5GMS_Multicast | 44 | new | Rel-17 | 87 | peng.tan@telus.com |  |
| 1308 | 632 | Study on location enhancements for mission critical services |  | 390d? | 2018-09-14 A | 2020-03-12 A | 100% |  |  | finish no earlier than 2020-03-12 | S6 | 3120h | 3120h | FS_enhMCLoc | 41 | 23.744 | Rel-17 | 81 | dom.lazara@motorolasolutions.com |  |
| 1309 | 633 | Study on Security Aspects of Enhancements for 5G Multicast-Broadcast Services |  | 391d | 2020-06-12 A | 2021-12-10 A | 100% |  |  | finish no earlier than 2021-12-12 | S3 | 3128h | 3128h | FS_5MBS_SEC | 45 | 33.850 | Rel-17 | 88 | guolonghua@huawei.com |  |
| 1310 | 634 | Study on Mission Critical services over 5G multicast-broadcast system |  | 126d | 2019-09-19 A | 2020-03-12 A | 100% |  |  | finish no earlier than 2020-03-12 | S6 | 1008h | 1008h | FS_MC5MBS | 43 | New ; 23.774; 33.524 | Rel-17 | 85 |  |  |

Notes:
- 1280: compare REL-16 WI NR_RF_FR2_req_enh ; 6/1/21: WID:RP-202107->RP-202409; 7/4/21: WID:RP-202409->RP-210914; 2/7/21: WID:RP-210914->RP-211538; 2/7/21: 38.851 added;; 29/9/21: WID:RP-211538->RP-212092; 6/1/22: WID:RP-212092->RP-213666; 5/4/22: WID:RP-21366 ; 12/7/22: WID:RP-220968->RP-221784 / WI rapporteur name: Nokia
- 1281: compare REL-16 WI NR_RF_FR2_req_enh ; 13/9/21: Compl:0%->55%; ; 22/3/22: Compl:55%->75%; 20/6/22: Rapporteur: Nokia->Vasenkari, Petri, Nokia; Rap eMail: ->Petri.j.vasenkari@nokia.com; / WI rapporteur name: Vasenkari, Petri, Nokia
- 1282: compare REL-16 WI NR_RF_FR2_req_enh ; 13/9/21: Compl:0%->25%; ; 22/3/22: CD:22/06/2022->10/06/2022 ; 20/6/22: Rapporteur: Nokia->Vasenkari, Petri, Nokia; Rap eMail: ->Petri.j.vasenkari@nokia.com 9/9/22: Compl:80%... / WI rapporteur name: Vasenkari, Petri, Nokia
- 1283: 9/12/22: FCD:10/12/2023->01/12/2023; Compl:0%->6%; Stat Rep: ->RP-222732; Rapporteur: Nokia->Tuomo S yn j kangas, Ashwin Mohan, Nokia, Apple; Rap eMail: ->tuomo.saynajakangas@nokia.com ashwin_mohan@apple.com; 17/3/23: FCD:30/11/2023->12/12/2023; Com.....; 2/4/24: WID:RP-221932->RP-240751 / WI rapporteur name: Tuomo S yn j kangas, Ashwin Mohan, Nokia, Apple
- 1284: follow-up WI of REL-16 WI NR_HST; TR 38.8xx ; 6/1/21: WID:RP-202118->RP-202538; 7/4/21: WID:RP-202538->RP-210800 / WI rapporteur name: Samsung
- 1285: follow-up WI of REL-16 WI NR_HST; TR 38.8xx ; 13/9/21: Compl:0%->50%; ; 20/6/22: Rapporteur: Samsung->WANG, He (Jackson), Samsung; Rap eMail: ->h0809.wang@samsung.com; / WI rapporteur name: WANG, He (Jackson), Samsung
- 1286: follow-up WI of REL-16 WI NR_HST ; 13/9/21: Compl:0%->20% ; 22/3/22: Compl:20%->50%; 20/6/22: Rapporteur: Samsung->WANG, He (Jackson), Samsung; Rap eMail: ->h0809.wang@samsung.com ; 9/9/22: Compl:80%->100% / WI rapporteur name: WANG, He (Jackson), Samsung
- 1287: 9/9/22: Comp...; 9/12/22: FCD:23/12/2022->01/12/2023; Stat Rep: ->R5-226806; Rapporteur: Samsung->Runsen Tang, Samsung; Rap eMail: ->runsen.tang@samsung.com; 17/3/23: FCD:30/11/2023->12/12/2023; Compl:7%->18%; Stat Rep: R5-226806->RP-2301.....; 14/3/24: FCD:05/06/2024->06/06/2024; Compl:42%->44%; Stat Rep: RP-233141->RP-240370; / WI rapporteur name: Runsen Tang, Samsung
- 1288: measurement gaps were introduced for NR in REL-15 WI NR_newRAT ; 6/1/21: WID:RP-202119->RP-202658; 7/4/21: WID:RP-202658->RP-210679; 2/7/21: WID:RP-210679->RP-211591; 6/1/22: WID:RP-211591->RP-213658 / WI rapporteur name: MediaTek
- 1289: measurement gaps were introduced for NR in REL-15 WI NR_newRAT ; 20/6/22: FCD:08/09/2021->22/03/2023; Compl:0%->100%; WID: RP-213658->RP-220772; Stat Rep: ->RP-221549; Rapporteur: MediaTek->Ato (Tsang-Wei) YU, Rui HUANG, MediaTek Inc., Intel Corporation; Rap eMail: ->ato.yu@mediatek.com, rui.huang@intel.com; / WI rapporteur name: Ato (Tsang-Wei) YU, Rui HUANG, MediaTek Inc., Intel Corporation
- 1290: measurement gaps were introduced for NR in REL-15 WI NR_newRAT ; 20/6/22: FCD:22/03/2023->22/09/2022; Compl:100%->40%; Rapporteur: MediaTek->Ato (Tsang-Wei) YU, Rui HUANG, MediaTek Inc., Intel Corporation; Rap eMail: ->ato.yu@mediatek.com, rui.... / WI rapporteur name: Ato (Tsang-Wei) YU, Rui HUANG, MediaTek Inc., Intel Corporation
- 1291: compare REL-16 WI NR_RF_FR1 ; 6/1/21: WID:RP-202088->RP-202799; 7/4/21: WID:RP-202799->RP-210899; 29/9/21: WID:RP-210899->RP-212527; 5/4/22: WID:RP-212527->RP-220681 / WI rapporteur name: Huawei
- 1292: compare REL-16 WI NR_RF_FR1 ; 13/9/21: Compl:0%->60%; ; 22/3/22: Compl:60%->90%; 20/6/22: Rapporteur: Huawei->Liu Ye, Huawei, HiSilicon; Rap eMail: ->leo.liuye@huawei.com; / WI rapporteur name: Liu Ye, Huawei, HiSilicon
- 1293: compare REL-16 WI NR_RF_FR1 ; 13/9/21: CD:Sat 11/12/21->Wed 22/09/21; ; 22/3/22: CD:22/09/2021->12/09/2022; 22/3/22: Stat Rep: RP-212170->RP-220680 ; 20/6/22: Rapporteur: Huawei->Liu Ye, Huawei, HiSilicon; Rap eMail: ->leo.liuye@huawei.com12/7/22... / WI rapporteur name: Liu Ye, Huawei, HiSilicon
- 1294: 9/9/22: Comp...; 9/12/22: FCD:23/12/2022->01/12/2023; Stat Rep: ->RP-223222; Rapporteur: Huawei->Chunying GU, Huawei; Rap eMail: ->guchunying@huawei.com; 17/3/23: FCD:30/11/2023->12/12/2023; Compl:11%->20%; Stat Rep: RP-223222->RP-230702;.....; 14/3/24: FCD:05/06/2024->01/03/2024; Compl:50%->100%; Stat Rep: RP-233762->RP-240280; / WI rapporteur name: Chunying GU, Huawei
- 1295: 5/4/22: WID:RP-213659->RP-220395 / WI rapporteur name: CHTTL
- 1296: ; / WI rapporteur name: CHTTL
- 1297: ; / WI rapporteur name: CHTTL
- 1298: 9/9/22: Comp...; 23/9/22: WID:RP-221159->RP-222137 / WI rapporteur name: ChinaUnicom
- 1300: affects: LTE, NR. no Perf. part; compare REL-16 SI FS_LTE_NR_data_collect and REL-16 WI NR_SON_MDT-Core; includes EN-DC and MR-DC changes and therefore LTE changes; 6/1/22: WID:RP-193255->RP-213574; 5/4/22: WID:RP-213574->RP-220821 / WI rapporteur name: CMCC
- 1301: affects: LTE, NR. no Perf. part; compare REL-16 SI FS_LTE_NR_data_collect and REL-16 WI NR_SON_MDT-Core; includes EN-DC and MR-DC changes and therefore LTE changes; 28/7/20: WID:RP-193255->RP-201281; ; 6/1/22: WID:RP-193255->RP-213574; 20/6/22: Compl:65%->100%; WID: RP-220821->RP-213574; Stat Rep: RP-211998->RP-220820; Rapporteur: CMCC->Liang LIU, AngeloCentonza; Rap eMail: ->liuliang@chinamobile.com, angelo.centonza@ericsson.com; / WI rapporteur name: Liang LIU, AngeloCentonza
- 1302: ; 11/6/21: 0%->10; 13/9/21: 10%->20; 13/12/21: 20%->70; 13/12/21: FCD:Fri 10/06/->03/22; 12/3/22: 70%->100 / WI rapporteur name: Per Elmdahl, Ericsson
- 1303: ; 13/9/20: 0%->2; 5/12/20: 2%->5; 21/3/21: 5%->15; 11/6/21: 15%->35; 11/6/21: FCD:Thu 17/06/->12/21; 13/9/21: 35%->70; 13/12/21: 70%->90; 13/12/21: FCD:Fri 10/12/->03/22; 21/6/22: 90%->100 / WI rapporteur name: Joey Chou, Intel
- 1304: ; 8/10/19: 28.810 added;; 26/3/20: 0%->50; 26/3/20: FCD:12/03/2020->06/20; 28/6/20: 50%->85; 13/9/20: 85%->100; 13/9/20: FCD:12/06/2020->09/20. 9/4/21: Rel-16->Rel-17 / WI rapporteur name: China Mobile
- 1305: 28.533; 28.313; 28.535; 28.809; 28.312; 28.541 ; 13/9/20: 0%->5; 13/9/20: FCD:11/12/2020->06/21; 5/12/20: 5%->30; 21/3/21: 30%->50; 11/6/21: 50%->70; 13/9/21: 70%->71; 13/9/21: FCD:Fri 11/06/->12/21; 13/12/21: 71%->100 / WI rapporteur name: Cao, Xi, China Mobile
- 1307: 10/6/20: 0%->5; 5/12/20: 5%->25; 5/12/20: FCD:17/12/2020->06/20; 21/3/21: 25%->60; 11/6/21: 60%->100 / WI rapporteur name: Peng Tan, Telus
- 1308: 7/12/18: 0%->20¦14/3/19: 20%->45¦14/3/19: FCD:03/19->09/19; 31/5/19: 45%->60; 13/9/19: 60%->70; 13/9/19: FCD:12/09/2019->03/20; 20/9/19: WID:SP-180921->SP-190725; 6/12/19: 70%->75; 28/6/20: 75%->90. Moved from Rel-16; 5/12/20: 90%->100 / WI rapporteur name: Dom Lazara, Motorola Solutions
- 1309: 28/7/20: 33.850 added;; 12/9/20: 0%->15; 5/12/20: 15%->30; 19/3/21: 30%->60; 19/3/21: FCD:25/03/2021->06/21; 11/6/21: 60%->75; 11/6/21: FCD:Fri 11/06/->12/21; 13/9/21: 75%->85; 12/3/22: 85%->100 / WI rapporteur name: Longhua Guo, Huawei Technologies
- 1310: ; 13/9/19: 0%->20; 8/10/19: 23.774 added;; 8/10/19: 33.524 added;; 6/12/19: 20%->55; 26/3/20: 55%->100 / WI rapporteur name: Val Oprescu, AT&T

| ID | WBS | Task | Type | Duration | Start | Finish | Complete | Remaining | Total slack | Constraint | Resources | Work | Actual work | Acronym | PCG approved | WI rapporteur name | WI rapporteur e-mail | Release | TSG approved | Status Report |
| --- | --- | --- | --- | --- | --- | --- | --- | --- | --- | --- | --- | --- | --- | --- | --- | --- | --- | --- | --- | --- |
| 1311 | 635 | **Multicast-broadcast services in 5G** |  | 1305d | 2019-03-07 A | 2024-03-03 A | 100% |  |  |  |  | 15743h | 15743h | 5MBS | 46 | Meng Li, Huawei | raymond.limeng@huawei.com | Rel-17 | 90 |  |
| 1312 | 635.1 | Study on Architectural enhancements for 5MBS |  | 526.88d | 2019-03-07 A | 2021-03-12 A | 100% |  |  | finish no earlier than 2021-03-12 | S2 | 4215h | 4215h | FS_5MBS | 42 | Meng Li, Huawei | raymond.limeng@huawei.com | Rel-17 | 83 |  |
| 1313 | 635.2 | Stage 2 for 5MBS |  | 202d | 2020-12-03 A | 2021-09-10 A | 100% |  |  | finish no earlier than 2021-09-12 | S2 | 1616h | 1616h | 5MBS | 46 | Meng Li, Huawei | raymond.limeng@huawei.com | Rel-17 | 90 |  |
| 1314 | 635.3 | CT1 aspects of 5MBS |  | 196d | 2021-06-11 A | 2022-03-11 A | 100% |  |  | finish no earlier than 2022-03-12 | C1 | 1568h | 1568h | 5MBS | 47 | Gulbani, Giorgi, Huawei | giorgi.gulbani@huawei.com | Rel-17 | 92 |  |
| 1315 | 635.4 | CT3 aspects of 5MBS |  | 196d | 2021-06-11 A | 2022-03-11 A | 100% |  |  | finish no earlier than 2022-03-12 | C3 | 1568h | 1568h | 5MBS | 47 | Gulbani, Giorgi, Huawei | giorgi.gulbani@huawei.com | Rel-17 | 92 |  |
| 1316 | 635.5 | CT4 aspect of 5MBS |  | 196d | 2021-06-11 A | 2022-03-11 A | 100% |  |  | finish no earlier than 2022-03-12 | C4 | 1568h | 1568h | 5MBS | 46 | Gulbani, Giorgi, Huawei | giorgi.gulbani@huawei.com | Rel-17 | 91 |  |
| 1317 | 635.6 | CT6 aspects of 5MBS |  | 196d | 2021-06-11 A | 2022-03-11 A | 100% |  |  | finish no earlier than 2022-03-12 | C6 | 1568h | 1568h | 5MBS | 49 | Gulbani, Giorgi, Huawei | giorgi.gulbani@huawei.com | Rel-17 | 96 |  |
| 1318 | 635.7 | Security Aspects of Enhancements for 5G Multicast-Broadcast Services |  | 261d | 2021-06-11 A | 2022-06-10 A | 100% |  |  | finish no earlier than 2022-06-12 | S3 | 2088h | 2088h | 5MBS | 47 | Longhua Guo, Huawei Technologies | guolonghua@huawei.com | Rel-17 | 92 |  |
| 1319 | 635.8 | Charging Aspects for SMF and MB-SMF to Support 5G Multicast-broadcast Services |  | 194d | 2023-06-08 A | 2024-03-03 A | 100% |  |  | finish no earlier than 2024-03-03 | S5 | 1552h | 1552h | 5MBS_CH | 51 | Dong, Jia, China Mobile, | dongjia at chinamobile dot com | Rel-18 | 100 |  |
| 1320 | 636 | Broadcast / Multicast requirements supporting Mission Critical Services in 5G |  | 74d | 2019-09-02 A | 2019-12-12 A | 100% |  |  | finish no earlier than 2019-12-12 | S1 | 592h | 592h | 5MBS_eMC | 43 | Toobe, Jens, BDBOS | jens.toobe at bdbos.bmi.bund.de | Rel-17 | 85 |  |
| 1321 | 637 | 5G Multicast-Broadcast Protocols |  | 131d | 2021-12-10 A | 2022-06-10 A | 100% |  |  | finish no earlier than 2022-06-12 | S4 | 1048h | 1048h | 5MBP3 | 48 | Thomas Stockhammer, Qualcomm Incorporated | tsto@QTI.QUALCOMM.COM | Rel-17 | 94 |  |
| 1322 | 638 | **NR multicast and broadcast services** |  | 1044d | 2019-12-16 A | 2023-12-12 | 99% | 0d | 0d |  | R2 | 15568h | 9750.34h | NR_MBS | 44 | Huawei |  | Rel-17 | 86 |  |
| 1323 | 638.1 | Core part: NR multicast and broadcast services |  | 585d | 2019-12-16 A | 2022-03-11 A | 100% |  |  | finish no earlier than 2022-03-12 | R2 | 4680h | 4680h | NR_MBS-Core | 44 | Huawei |  | Rel-17 | 86 | RP-220407 |
| 1324 | 638.2 | UE Conformance - NR Multicast and Broadcast Services including CT and SA aspects |  | 457d | 2022-03-15 A | 2023-12-12 A | 100% |  |  | finish no earlier than 2023-12-12 | R5 | 3656h | 3656h | NR_MBS_5MBS_5MBUSA-UEConTest | 48 | Ya Zhao, Huawei Technologies. Co., Ltd | zhaoya@hisilicon.com | Rel-17 | 95 | RP-233760 |
| 1325 | 639 | **Mission Critical Services over 5GS** |  | 389d | 2020-09-16 A | 2022-03-11 A | 100% |  |  |  |  | 3128h | 3128h | MCOver5GS | 45 | Wendler, Ingo, UIC | ingo.wendler@sbb.ch | Rel-17 | 89 |  |
| 1326 | 639.1 | Stage 2 of MCOver5GS |  | 195d | 2020-09-16 A | 2021-06-15 A | 100% |  |  | finish no earlier than 2021-06-15 | S6 | 1560h | 1560h | MCOver5GS | 45 | Wendler, Ingo, UIC | ingo.wendler@sbb.ch | Rel-17 | 89 |  |
| 1327 | 639.2 | CT1 aspects of MCOver5GS |  | 196d | 2021-06-11 A | 2022-03-11 A | 100% |  |  | finish no earlier than 2022-03-12 | C1 | 1568h | 1568h | MCOver5GS | 47 | Gkatzikis, Lazaros, Nokia | lazaros(dot)gkatzikis(at)nokia(dot)com | Rel-17 | 92 |  |
| 1328 | 640 | **Mission Critical Data** |  | 592d | 2019-12-06 A | 2022-03-11 A | 100% |  |  |  |  | 6808h | 6808h | eMCData3 | 44 | Shih, Jerry, AT&T | jerry.shih@att.com | Rel-17 | 86 |  |
| 1329 | 640.1 | Stage 2 of MCData3 |  | 398d | 2019-12-06 A | 2021-06-15 A | 100% |  |  | finish no earlier than 2021-06-15 | S6 | 3184h | 3184h | eMCData3 | 44 | Shih, Jerry, AT&T | jerry.shih@att.com | Rel-17 | 86 |  |
| 1330 | 640.2 | CT aspects of eMCData3 |  | 453d | 2020-06-17 A | 2022-03-11 A | 100% |  |  | finish no earlier than 2022-03-12 | C1 | 3624h | 3624h | eMCData3 | 45 |  |  | Rel-17 | 89 |  |
| 1331 | 641 | Protocol enhancements for Mission Critical Services |  | 381d | 2020-09-25 A | 2022-03-11 A | 100% |  |  | finish no earlier than 2022-03-12 | C1 | 3048h | 3048h | MCProtoc17 | 45 | AXELL, Jörgen | jorgen.axell@ericsson.com | Rel-17 | 88 |  |
| 1332 | 642 | Mission Critical system migration and interconnection |  | 847d | 2018-12-13 A | 2022-03-11 A | 100% |  |  | finish no earlier than 2022-03-12 | C1 | 6776h | 6776h | MCSMI_CT | 42 | Dom Lazara, Motorola Solutions | dom.lazara@motorolasolutions.com | Rel-17 | 82 |  |
| 1333 | 643 | CT aspects of Enhanced Mission Critical Communication Interworking with Land Mobile Radio Systems |  | 256d | 2020-09-16 A | 2021-09-08 | 65% | 89.6d | 1173d | finish no earlier than 2021-09-08 | C1 | 2048h |  | eMCCI_CT | 45 | Mike Dolan, FirstNet | michael.dolan@firstnet.gov | Rel-17 | 89 |  |
| 1334 | 644 | Rel-17 Edge computing | milestone, manual | 0d | 2016-06-09 A | 2016-06-09 A | 100% |  |  | finish no earlier than 2016-06-09 |  |  |  |  |  |  |  | Rel-17 |  |  |

Notes:
- 1311: 23.501; 23.502; 23.503
- 1312: 7/6/19: WID:SP-190253->SP-190442; 20/9/19: WID:SP-190442->SP-190625; 6/12/19: 0%->15; 25/3/20: WID:SP-190625->SP-200092; 25/3/20: 15%->35; 26/6/20: FCD:12/06/2020->09/20; 26/6/20: 35%->50; 12/9/20: 50%->65; 12/9/20: FCD:15/09/2020->12/20; 13/9/20: WID: / Impacted TSs and TRs: 23.757
- 1313: 23.501; 23.502; 23.503 ; 19/3/21: 0%->20; 14/6/21: 20%->75; 13/9/21: 75%->85; 10/12/21: 85%->95; 12/3/22: 95%->99; 4/6/22: 99%->100
- 1314: ; 13/9/21: 0%->45; 13/12/21: 45%->80; 12/3/22: 80%->95; 22/3/22: 24.575 added;; 22/3/22: WID:CP-212022->CP-220402; 4/6/22: 95%->97 / Impacted TSs and TRs: 24.501 ; 24.575
- 1315: ; 13/12/21: 0%->40; 13/12/21: WID:CP-212022->CP-213078; 12/3/22: WID:CP-213078->CP-220099; 12/3/22: 40%->65; 22/3/22: 29.580 added;; 4/6/22: 65%->85; 4/6/22: WID:CP-220402->CP-221084; 20/6/22: WID: eSEALCP-221084->CP-220402 / Impacted TSs and TRs: 29.561;29.525;29.522;29.521;29.520;29.519;29.514;29.513;29.512;29.508 ; 29.580
- 1316: UID in 91xx range but presented to CT#92; 2/7/21: 29.532 added;; 10/9/21: WID:CP-211093->CP-212022; 13/9/21: 0%->15; 13/12/21: 15%->75; 7/1/22: 29.537 added;; 12/3/22: 75%->80; 22/3/22: 29.581 added;; 20/6/22: Compl:80%->99% / Impacted TSs and TRs: 29.571;29.518;29.510;29.503;29.502;29.281;29.244;23.003 ; 29.532; 29.537; 29.581
- 1318: ; 12/3/22: 0%->95; 12/3/22: FCD:10/12/2021->6/22; 4/6/22: 95%->100 / Impacted TSs and TRs: 33.501
- 1319: ; 7/9/23: 0%->20; 7/9/23: 20%->30; 8/12/23: 30%->65; 3/1/24: WID:SP-230623->SP-231712; 14/3/24: 65%->100 / Impacted TSs and TRs: 32.240; 32.255; 32.298; 32.291; 33.279; 33.290
- 1320: ; 13/9/19: 0%->80; 20/9/19: FCD:19/09/2019->12/19; 6/12/19: 80%->100 / Impacted TSs and TRs: 22.261
- 1321: ; 12/3/22: 0%->40; 12/3/22: FCD:15/03/2022->6/22; 4/6/22: 40%->100 / Impacted TSs and TRs: 26.346; 26.347; 26.512
- 1322: affects: NR. no Perf. part; 5/4/22: WID:RP-193248->RP-220428
- 1323: affects: NR. no Perf. part; 28/7/20: WID:RP-193248->RP-201038 ;
- 1324: tested: REL-17 WI NR_MBS-Core, SA/CT REL-17 WI 5MBS, SA4 REL-17 WI 5MBUSA ; 6/6/22: Compl:0%->5% ; 20/6/22: Rapporteur: Huawei->Ya Zhao, Huawei Technologies. Co., Ltd; Rap eMail: ->zhaoya@hisilicon.com ...; 9/12/22: FCD:23/06/2023->01/06/2023; Compl...; 8/12/23: Compl:90%->100%; Stat Rep: RP-232352->RP-233760;
- 1325: 25/9/20: 23.289 added;; 5/12/20: 0%->30; 5/12/20: FCD:11/12/2020->03/20; 10/2/21: FCD:12/03/2021->06/21; 21/3/21: 30%->65 / Impacted TSs and TRs: 23.289
- 1326: 25/9/20: 23.289 added;; 5/12/20: 0%->30; 5/12/20: FCD:11/12/2020->03/20; 10/2/21: FCD:12/03/2021->06/21; 21/3/21: 30%->65; 11/6/21: 65%->100 / Impacted TSs and TRs: 23.289
- 1327: ; 13/12/21: 0%->25; 12/3/22: 25%->40; 4/6/22: 40%->100 / Impacted TSs and TRs: 24.582;24.581;24.484;24.483;24.481;24.380;24.379;24.282;24.281
- 1328: ; 26/3/20: 0%->15; 28/6/20: 15%->45; 13/9/20: 45%->70 / Impacted TSs and TRs: 23.280; 23.282
- 1329: ; 26/3/20: 0%->15; 28/6/20: 15%->45; 13/9/20: 45%->70; 5/12/20: 70%->85; 10/2/21: FCD:11/09/2020->06/21; 21/3/21: 85%->90; 11/6/21: 90%->100 / Impacted TSs and TRs: 23.280; 23.282
- 1330: 5/12/20: 0%->10; 21/3/21: 10%->40; 11/6/21: 40%->45; 13/9/21: 45%->50; 13/12/21: 50%->65; 12/3/22: FCD:15/09/2021->3/22; 12/3/22: 65%->97; 4/6/22: 97%->100
- 1331: 24.229; 24.281; 24.282; 24.379; 24.380; 24.481; 24.482; 24.483; 24.484; 24.581; 24.582; 29.379; 29.380; 29.582 ; 13/9/20: 0%->10; 25/9/20: WID:CP-201164->CP-202193; 5/12/20: 10%->30; 21/3/21: 30%->40; 11/6/21: 40%->50; 13/9/21: 50%->70; 13/12/21: 70%->
- 1332: ¦18/3/19: FCD:019->12/19¦18/3/19: WID:CP-183244->CP-190143; 13/9/19: 0%->5. 1/7/20: Rel-16->Rel-17 (comments during CT#88e presentation); 13/9/21: 5%->10; 13/12/21: 10%->30; 12/3/22: 30%->90; 12/3/22: FCD:12/12/2019->3/22; 4/6/22: 90%->100 / Impacted TSs and TRs: 24.379; 24.380; 24.282; 24.481; 24.483; 24.484; 24.482
- 1333: 5/12/20: 0%->60; 13/9/21: 60%->65 / Impacted TSs and TRs: 29.379; 29.380; 29.582
- 1334: Impacted TSs and TRs: 26.234; 26.247

| ID | WBS | Task | Type | Duration | Start | Finish | Complete | Constraint | Resources | Work | Actual work | Acronym | PCG approved | Impacted TSs and TRs | WI rapporteur name | WI rapporteur e-mail | Release | TSG approved |
| --- | --- | --- | --- | --- | --- | --- | --- | --- | --- | --- | --- | --- | --- | --- | --- | --- | --- | --- |
| 1335 | 645 | **Architecture for enabling Edge Applications** |  | 850d | 2019-03-07 A | 2022-06-07 A | 100% |  |  | 13159.1h | 13159.1h | EDGEAPP | 44 | 23.222; 23.558 | Basavaraj (Basu) Pattan, Samsung | basavarajjp@samsung.com | Rel-17 | 86 |
| 1336 | 645.1 | Study on Application Architecture for enabling Edge Applications |  | 195.88d | 2019-03-07 A | 2019-12-05 A | 100% |  | S6 | 1567h | 1567h | FS_EDGEAPP | 42 | New | Basavaraj (Basu) Pattan, Samsung | basavarajjp@samsung.com | Rel-17 | 83 |
| 1337 | 645.2 | Architecture for enabling Edge Applications |  | 398d | 2019-12-06 A | 2021-06-15 A | 100% | finish no earlier than 2021-06-15 | S6 | 3184h | 3184h | EDGEAPP | 44 | 23.222; 23.558 | Basavaraj (Basu) Pattan, Samsung | basavarajjp@samsung.com | Rel-17 | 86 |
| 1338 | 645.3 | **CT aspects for Enabling Edge Applications** |  | 393d | 2020-12-07 A | 2022-06-07 A | 100% |  |  | 8408.08h | 8408.08h | EDGEAPP | 46 |  | Narendranath Durga Tangudu | n.tangudu@samsung.com | Rel-17 | 90 |
| 1339 | 645.3.1 | CT1 aspects for EDGEAPP |  | 330d | 2020-12-07 A | 2022-03-11 A | 100% | finish no earlier than 2022-03-12 | C1 | 2640h | 2640h | EDGEAPP | 46 |  | Narendranath Durga Tangudu | n.tangudu@samsung.com | Rel-17 | 90 |
| 1340 | 645.3.2 | CT3 aspects for EDGEAPP |  | 330d | 2020-12-07 A | 2022-03-11 A | 100% | finish no earlier than 2022-03-12 | C3 | 2640h | 2640h | EDGEAPP | 46 |  | Narendranath Durga Tangudu | n.tangudu@samsung.com | Rel-17 | 90 |
| 1341 | 645.3.3 | CT4 aspects for EDGEAPP |  | 391.01d | 2020-12-07 A | 2022-06-07 A | 100% | finish no earlier than 2022-06-07 | C4 | 3128.08h | 3128.08h | EDGEAPP | 46 |  | Narendranath Durga Tangudu | n.tangudu@samsung.com | Rel-17 | 90 |
| 1342 | 646 | Study on enhancement of support for Edge Computing in 5GC |  | 463.88d | 2019-03-07 A | 2020-12-15 A | 100% | finish no earlier than 2020-12-15 | S2 | 3711h | 3711h | FS_enh_EC | 42 | New | Hui Ni, Huawei | Hui.ni@huawei.com | Rel-17 | 83 |
| 1343 | 647 | **Enhancement of support for Edge Computing in 5G Core network** |  | 333d | 2020-12-03 A | 2022-03-11 A | 100% |  |  | 10872h | 10872h | eEDGE_5GC | 46 |  | Hui Ni, Huawei Technologies | hui.ni@huawei.com | Rel-17 | 90 |
| 1344 | 647.1 | Stage 2 of eEDGE_5GC |  | 200d | 2020-12-03 A | 2021-09-08 A | 100% | finish no earlier than 2021-09-08 | S2 | 1600h | 1600h | eEDGE_5GC | 46 |  | Hui Ni, Huawei Technologies | hui.ni@huawei.com | Rel-17 | 90 |
| 1345 | 647.2 | **CT aspects of 5G eEDGE** |  | 258d | 2021-03-18 A | 2022-03-11 A | 100% |  | ct | 8224h | 8224h | eEDGE_5GC | 46 |  | Qi Caixia, Huawei | caixia.qi@huawei.com | Rel-17 | 91 |
| 1346 | 647.2.1 | CT1 aspects of 5G eEDGE |  | 257d | 2021-03-18 A | 2022-03-11 A | 100% | finish no earlier than 2022-03-12 | C1 | 2056h | 2056h | eEDGE_5GC | 46 | 24.008; 24.501; 24.526; 27.007 | Qi Caixia, Huawei | caixia.qi@huawei.com | Rel-17 | 91 |
| 1347 | 647.2.2 | CT3 aspects of 5G eEDGE |  | 257d | 2021-03-18 A | 2022-03-11 A | 100% | finish no earlier than 2022-03-12 | C3 | 2056h | 2056h | eEDGE_5GC | 46 | 29.508; 29.512; 29.514; 29.513; 29.522; 29.519; 29.561 | Qi Caixia, Huawei | caixia.qi@huawei.com | Rel-17 | 91 |
| 1348 | 647.2.3 | CT4 aspects of 5G eEDGE |  | 257d | 2021-03-18 A | 2022-03-11 A | 100% | finish no earlier than 2022-03-12 | C4 | 2056h | 2056h | eEDGE_5GC | 46 | 29.244; 29.510; 29.502; 29.503; 29.505; 29.571; 29.564 | Qi Caixia, Huawei | caixia.qi@huawei.com | Rel-17 | 91 |
| 1349 | 647.3 | Security Aspects of Enhancements of Support for Edge Computing in 5GC |  | 131d | 2021-06-11 A | 2021-12-10 A | 100% | finish no earlier than 2021-12-12 | S3 | 1048h | 1048h | eEDGE_5GC | 47 | 33.501 ; 33.558 | Bo Zhang, Huawei Technologies | zhangbo6@huawei.com | Rel-17 | 92 |
| 1350 | 648 | Edge Computing Management |  | 196d | 2021-06-11 A | 2022-03-11 A | 100% | finish no earlier than 2022-03-12 | S5 | 1568h | 1568h | ECM | 47 | 28.532;28.531;28.554;28.552;28.541 | Deepanshu Gautam, Samsung | deepanshu<dot>g<at>samsung<dot>com | Rel-17 | 92 |
| 1351 | 649 | Study on Security Aspects of Enhancement of Support for Edge Computing in 5GC |  | 391d | 2020-06-12 A | 2021-12-10 A | 100% | finish no earlier than 2021-12-12 | S3 | 3128h | 3128h | FS_eEDGE_Sec | 45 | 33.839 | Bo Zhang, Huawei Technologies | zhangbo6@huawei.com | Rel-17 | 88 |
| 1352 | 650 | Edge Extensions to 5GMS Stage 3 |  | 131d | 2021-12-10 A | 2022-06-10 A | 100% | finish no earlier than 2022-06-12 | S4 | 1048h | 1048h | 5GMS_EDGE_3 | 48 | 26.512; | Bouazizi, Imed, Qualcomm Inc. | bouazizi@qti.qualcomm.com | Rel-17 | 94 |
| 1353 | 651 | **Charging aspects of Edge Computing** |  | 448d | 2020-06-25 A | 2022-03-11 A | 100% |  | S5 | 7680h | 7680h | EDGE_CH | 47 | 32.240; 32.291; 32.298; 32.297 ; 32.257 | Yao, Yizhi, Intel | yizhi<dot>yao<at>intel<dot>com | Rel-17 | 93 |
| 1354 | 651.1 | Study on charging aspects of Edge Computing |  | 382d | 2020-06-25 A | 2021-12-10 A | 100% | finish no earlier than 2021-12-12 | S5 | 3056h | 3056h | FS_EDGE_CH | 45 | 28.815 | Yizhi Yao, Intel | yizhi<dot>yao<at>intel<dot>com | Rel-17 | 88 |
| 1355 | 651.2 | Charging aspects of Edge Computing |  | 131d | 2021-09-10 A | 2022-03-11 A | 100% | finish no earlier than 2022-03-12 | S5 | 1048h | 1048h | EDGE_CH | 47 | 32.240; 32.291; 32.298; 32.297 | Yao, Yizhi, Intel | yizhi<dot>yao<at>intel<dot>com | Rel-17 | 93 |
| 1356 | 652 | Study on enhancements of edge computing management |  | 381d | 2020-03-25 A | 2021-09-08 A | 100% | finish no earlier than 2021-09-08 | S5 | 3048h | 3048h | FS_eEDGE_Mgt | 44 | New | Joey Chou, Intel | joey<dot>chou<at>intel<dot>com | Rel-17 | 87 |
| 1357 | 653 | Rel-17 Slicing | milestone, manual | 0d | 2016-06-09 A | 2016-06-09 A | 100% | finish no earlier than 2016-06-09 |  |  |  |  |  | 26.234; 26.247 |  |  | Rel-17 |  |
| 1358 | 654 | **Rel-17 Enhancements of 3GPP Northbound Interfaces and Application Layer APIs** |  | 197d | 2021-06-11 A | 2022-03-11 A | 100% |  |  | 4704h | 4704h | NBI17 | 47 |  | Abdessamad El Moatamid, Huawei | abdessamad.el.moatamid@huawei.com | Rel-17 | 92 |
| 1359 | 654.1 | CT1 aspects of NBI17 |  | 196d | 2021-06-11 A | 2022-03-11 A | 100% | finish no earlier than 2022-03-12 | C1 | 1568h | 1568h | NBI17 | 47 | 24.558 | Abdessamad El Moatamid, Huawei | abdessamad.el.moatamid@huawei.com | Rel-17 | 92 |
| 1360 | 654.2 | CT3 aspects of NBI17 |  | 196d | 2021-06-11 A | 2022-03-11 A | 100% | finish no earlier than 2023-03-12 | C3 | 1568h | 1568h | NBI17 | 47 | 29.558;29.549;29.522;29.486;29.343;29.222;29.122;29.116 | Abdessamad El Moatamid, Huawei | abdessamad.el.moatamid@huawei.com | Rel-17 | 92 |
| 1361 | 654.3 | CT4 aspects of NBI17 |  | 196d | 2021-06-11 A | 2022-03-11 A | 100% | finish no earlier than 2022-03-12 | C4 | 1568h | 1568h | NBI17 | 47 | 29.518;29.503;29.272;29.336;29.571 | Abdessamad El Moatamid, Huawei | abdessamad.el.moatamid@huawei.com | Rel-17 | 92 |
| 1362 | 655 | Enhancement of 5G PCC related services in Rel-17 |  | 196d | 2021-06-11 A | 2022-03-11 A | 100% | finish no earlier than 2022-03-12 | C3 | 1568h | 1568h | en5GPccSer17 | 47 | 29.214;29.519;29.594;29.521;29.514;29.513;29.512 | Xiaoyun Zhou, Huawei | zhouxiaoyun8@huawei.com | Rel-17 | 92 |

Notes:
- 1335: 25/3/20: WID:SP-191105->SP-200109; 26/3/20: 0%->20
- 1336: 31/5/19: 0%->35; 13/9/19: 35%->70; 6/12/19: 70%->95; 26/3/20: 95%->100
- 1337: 25/3/20: WID:SP-191105->SP-200109; 26/3/20: 0%->20; 28/6/20: 20%->50; 13/9/20: 50%->70; 13/9/20: WID:SP-200109->SP-200834; 13/9/20: FCD:11/09/2020->12/20; 25/9/20: WID:SP-200834->SP-200886; 5/12/20: 70%->85; 10/2/21: FCD:11/12/2020->06/21; 21/3/21: 85%
- 1338: 29.222 ; 11/6/21: WID:CP-203106->CP-211196
- 1339: 29.222 ; 21/3/21: 0%->5; 11/6/21: 5%->30; 13/9/21: 30%->55; 13/12/21: 55%->68; 12/3/22: FCD:10/09/2021->3/22; 12/3/22: 68%->85; 4/6/22: 85%->99; 4/6/22: WID:CP-211196->CP-221106
- 1340: 29.222 ; 21/3/21: 0%->20; 11/6/21: FCD:Fri 10/09/->12/21; 11/6/21: 20%->50; 13/9/21: 50%->60; 13/12/21: 60%->75; 12/3/22: FCD:10/12/2021->3/22; 12/3/22: 75%->90
- 1341: CT4 chair input (07/06/2022); 3/8/22: 0%->100
- 1342: 6/12/19: 0%->20; 25/3/20: WID:SP-190185->SP-200093; 25/3/20: FCD:05/03/2020->06/20; 25/3/20: 20%->40; 26/6/20: FCD:15/06/2020->09/20; 26/6/20: 40%->60; 12/9/20: 60%->70; 12/9/20: FCD:11/09/2020->12/20; 5/12/20: 70%->100
- 1343: 23.501; 23.502; 23.503
- 1344: 23.501; 23.502; 23.503 ; 19/3/21: 0%->35; 11/6/21: 35%->75; 11/6/21: FCD:Fri 11/06/->09/21; 13/9/21: 75%->95; 10/12/21: 95%->100
- 1345: 10/9/21: WID:CP-211092->CP-212021
- 1346: 11/6/21: 0%->40; 13/9/21: 40%->65; 13/12/21: 65%->85; 12/3/22: 85%->95; 4/6/22: 95%->100
- 1347: 11/6/21: 0%->40; 11/6/21: WID:CP-210284->CP-211092; 13/9/21: 40%->65; 13/12/21: 65%->85; 12/3/22: 85%->100
- 1348: 11/6/21: 0%->25; 13/9/21: 25%->45; 1/10/21: 29.564 added;; 13/12/21: 45%->80; 12/3/22: 80%->98; 4/6/22: 98%->100
- 1349: ; 13/9/21: 0%->30; 1/10/21: 33.558 added;; 13/12/21: 30%->50; 12/3/22: 50%->100
- 1350: ; 13/9/21: 0%->10; 13/12/21: 10%->50; 12/3/22: 50%->90; 4/6/22: 90%->100
- 1351: 12/9/20: 0%->15; 5/12/20: 15%->50; 19/3/21: FCD:25/03/2021->06/21; 19/3/21: 50%->60; 11/6/21: 60%->75; 11/6/21: FCD:Fri 11/06/->12/21; 13/9/21: 75%->85; 12/3/22: 85%->100
- 1352: ; 12/3/22: 0%->60; 12/3/22: FCD:11/03/2022->6/22; 4/6/22: 60%->100
- 1353: ; 22/3/22: 32.257 added;
- 1354: 5/12/20: 0%->30; 21/3/21: 30%->60; 21/3/21: FCD:19/03/2021->09/21; 13/9/21: 60%->90; 13/9/21: FCD:Wed 08/09/->12/21; 21/6/22: 90%->100
- 1355: ; 12/3/22: 0%->70; 4/6/22: 70%->100
- 1356: 13/9/20: 0%->15; 5/12/20: 15%->25; 5/12/20: FCD:17/12/2020->03/20; 21/3/21: 25%->75; 11/6/21: 75%->90; 11/6/21: FCD:Fri 12/03/->09/21; 13/9/21: 90%->100
- 1358: 01/22: Rapp changed from yanyali@huawei.com ; 28/4/22: WID:CP-211197->CP-220058
- 1359: ; 13/9/21: 0%->85; 13/12/21: 85%->95; 12/3/22: 95%->99; 4/6/22: 99%->100; 20/6/22: WID: CP-220058->CP-211197
- 1360: ; 11/6/21: 0%->35; 13/9/21: 35%->65; 13/12/21: 65%->85; 13/12/21: WID:CP-211197->CP-213262; 12/3/22: 85%->100; 12/3/22: FCD:10/03/2023->3/22
- 1361: ; 12/3/22: 0%->100
- 1362: ; 11/6/21: 0%->20; 13/9/21: 20%->35; 13/12/21: 35%->70; 12/3/22: 70%->100

| ID | WBS | Task | Type | Duration | Start | Finish | Complete | Remaining | Total slack | Constraint | Resources | Work | Actual work | Acronym | PCG approved | WI rapporteur name | WI rapporteur e-mail | Release | TSG approved | Impacted TSs and TRs | Status Report |
| --- | --- | --- | --- | --- | --- | --- | --- | --- | --- | --- | --- | --- | --- | --- | --- | --- | --- | --- | --- | --- | --- |
| 1363 | 656 | **Enhancement of Network Slicing Phase 2** |  | 970d | 2019-09-19 A | 2023-06-06 | 99% | 0d | 0d |  |  | 18064h | 16735.7h | eNS_Ph2 | 46 | ZTE, Jinguo Zhu | Zhu dot Jinguo at zte dot com dot cn | Rel-17 | 90 |  |  |
| 1364 | 656.1 | Study on Enhancement of Network Slicing Phase 2 |  | 387d | 2019-09-19 A | 2021-03-12 A | 100% |  |  | finish no earlier than 2021-03-12 | S2 | 3096h | 3096h | FS_eNS_Ph2 | 43 | So, Tricci, ZTE | tso@ztetx.com | Rel-17 | 85 | New ; 23.700-40 |  |
| 1365 | 656.2 | Stage 2 for Enhancement of Network Slicing Phase 2 |  | 200d | 2020-12-03 A | 2021-09-08 A | 100% |  |  | finish no earlier than 2021-09-08 | S2 | 1600h | 1600h | eNS_Ph2 | 46 | ZTE, Jinguo Zhu | Zhu dot Jinguo at zte dot com dot cn | Rel-17 | 90 |  |  |
| 1366 | 656.3 | **Stage 3 for Enhancement of Network Slicing Phase 2** |  | 580d | 2021-03-18 A | 2023-06-06 | 99% | 0d | 0d |  | ct | 13368h | 12039.7h | eNS_Ph2 | 46 | Hannah Wang, ZTE | wang.menghan@zte.com.cn | Rel-17 | 91 |  |  |
| 1367 | 656.3.1 | CT1 aspects of eNS_Ph2 |  | 257d | 2021-03-18 A | 2022-03-11 A | 100% |  |  | finish no earlier than 2022-03-12 | C1 | 2056h | 2056h | eNS_Ph2 | 46 | Hannah Wang, ZTE | wang.menghan@zte.com.cn | Rel-17 | 91 | 24.501 |  |
| 1368 | 656.3.2 | CT3 aspects of eNS_Ph2 |  | 257d | 2021-03-18 A | 2022-03-11 A | 100% |  |  | finish no earlier than 2022-03-12 | C3 | 2056h | 2056h | eNS_Ph2 | 46 | Hannah Wang, ZTE | wang.menghan@zte.com.cn | Rel-17 | 91 | 29.522 |  |
| 1369 | 656.3.3 | CT4 aspects of eNS_Ph2 |  | 257d | 2021-03-18 A | 2022-03-11 A | 100% |  |  | finish no earlier than 2022-03-12 | C4 | 2056h | 2056h | eNS_Ph2 | 46 | Hannah Wang, ZTE | wang.menghan@zte.com.cn | Rel-17 | 91 | 29.510; 29.518; 29.502; 29.524 |  |
| 1370 | 656.3.4 | UE Conformance - Enhancement of Network Slicing Phase 2 |  | 321d | 2022-03-15 A | 2023-06-06 A | 100% |  |  | finish no earlier than 2023-06-06 | R5 | 2568h | 2568h | eNS_Ph2-UEConTest | 48 | Danni Song, Xiaozhong Chen, CMCC, CATT | songdan@chinamobile.com, chenxiaozhong@catt.cn | Rel-17 | 95 |  | RP-230286 |
| 1371 | 657 | **Enhancement of RAN slicing for NR** |  | 1189d | 2019-03-07 A | 2023-09-22 A | 100% |  |  |  | R2 | 10744h | 10744h | NR_slice | 46 | CMCC |  | Rel-17 | 91 |  |  |
| 1372 | 657.1 | Core part: Enhancement of RAN slicing for NR |  | 334d | 2021-03-12 A | 2022-06-22 A | 100% |  |  | finish no earlier than 2022-06-22 | R2 | 2672h | 2672h | NR_slice-Core | 46 | Ningyu Chen, CMCC | chenningyu@chinamobile.com | Rel-17 | 91 |  | RP-221375 |
| 1373 | 657.2 | UE Conformance - Enhancement of RAN slicing for NR |  | 334d | 2022-06-15 A | 2023-09-22 A | 100% |  |  | finish no earlier than 2023-09-22 | R5 | 2672h | 2672h | NR_slice-UEConTest | 49 | Danni Song, CMCC | songdan@chinamobile.com | Rel-17 | 96 |  | RP-232242 |
| 1374 | 657.3 | CT1 aspects of enhancement of RAN Slicing for NR |  | 12d | 2022-06-03 A | 2022-06-20 A | 100% |  |  | finish no earlier than 2022-06-20 | C1 | 96h | 96h | NRslice | 49 | Chen Xu, China Mobile | chenxu@chinamobile.com | Rel-17 | 96 | 24.501; 29.531; 29.571 |  |
| 1375 | 657.4 | CT4 aspects on enhancement of RAN slicing for NR |  | 1d | 2019-03-07 A | 2019-03-07 A | 100% |  |  | finish no earlier than 2019-03-07 | C4 | 8h | 8h | NRslice | 49 | Chen Xu, China Mobile | chenxu@chinamobile.com | Rel-17 | 96 | 24.501; 29.531; 29.571 |  |
| 1376 | 658 | Study on network slice management enhancement |  | 526d | 2019-12-06 A | 2021-12-10 A | 100% |  |  | finish no earlier than 2021-12-12 | S5 | 4208h | 4208h | FS_NSMEN | 44 | Brendan Hassett, Huawei Technologies Sweden AB, | brendan.t.hassett@huawei.com | Rel-17 | 86 |  |  |
| 1377 | 659 | Network Slice charging based on 5G Data Connectivity |  | 2d | 2022-03-10 A | 2022-03-11 A | 100% |  |  | finish no earlier than 2022-03-12 | S5 | 16h | 16h | NETSLICE_DC_CH | 48 | MATRIXX Software, Gerald Görmer | Gerald dot Goermer at Matrixx dot com | Rel-17 | 95 | 32.255 |  |
| 1378 | 660 | Rel-17 Multi-(U)SIM | milestone, manual | 0d | 2016-06-09 A | 2016-06-09 A | 100% |  |  | finish no earlier than 2016-06-09 |  |  |  |  |  |  |  | Rel-17 |  | 26.234; 26.247 |  |
| 1379 | 661 | **Support for Multi-USIM Devices** |  | 788d? | 2019-03-07 A | 2022-03-11 A | 100% |  |  |  |  | 16247h | 16247h | MUSIM | 43 | Liao, Ellen C, Intel | ellen.c.liao@intel.com | Rel-17 | 84 | 22.261; 22.278; 22.101 |  |
| 1380 | 661.1 | Study on MUSIM |  | 130.88d? | 2019-03-07 A | 2019-09-06 A | 100% |  |  | finish no later than 2019-09-12 | S1 | 1047.04h | 1047.04h | FS_MUSIM | 42 | Liao, Ellen C, Intel | ellen.c.liao@intel.com | Rel-17 | 83 | New |  |
| 1381 | 661.2 | Stage 1 of MUSIM |  | 136d | 2019-06-06 A | 2019-12-12 A | 100% |  |  | finish no earlier than 2019-12-12 | S1 | 1088h | 1088h | MUSIM | 43 | Liao, Ellen C, Intel | ellen.c.liao@intel.com | Rel-17 | 84 | 22.261; 22.278; 22.101 |  |
| 1382 | 661.3 | Study on Stage 2 (System Enablers) for MUSIM |  | 527d | 2019-03-07 A | 2021-03-12 A | 100% |  |  | finish no earlier than 2021-03-12 | S2 | 4216h | 4216h | FS_MUSIM | 42 | Sašo Stojanovski, Intel | saso stojanovski intel com) | Rel-17 | 82 | 23.761 |  |
| 1383 | 661.4 | System enablers for Multi-USIM devices |  | 200d | 2020-12-03 A | 2021-09-08 A | 100% |  |  | finish no earlier than 2021-09-08 | S2 | 1600h | 1600h | MUSIM | 46 | Sašo Stojanovski, Intel | saso stojanovski intel com | Rel-17 | 90 |  |  |
| 1384 | 661.5 | **CT aspects of MUSIM** |  | 258d | 2021-03-18 A | 2022-03-11 A | 100% |  |  |  | ct | 6168h | 6168h | MUSIM | 46 | Thomas Luetzenkirchen, Intel | thomas.luetzenkirchen@intel.com | Rel-17 | 91 | 24.501; 24.301; 27.007; 29.274 |  |
| 1385 | 661.5.1 | CT1 aspects of Enabling Multi-USIM Devices |  | 257d | 2021-03-18 A | 2022-03-11 A | 100% |  |  | finish no earlier than 2022-03-12 | C1 | 2056h | 2056h | MUSIM | 46 | Thomas Luetzenkirchen, Intel | thomas.luetzenkirchen@intel.com | Rel-17 | 91 |  |  |
| 1386 | 661.5.2 | CT4 aspects of Enabling Multi-USIM Devices |  | 257d | 2021-03-18 A | 2022-03-11 A | 100% |  |  | finish no earlier than 2022-03-12 | C4 | 2056h | 2056h | MUSIM | 46 | Thomas Luetzenkirchen, Intel | thomas.luetzenkirchen@intel.com | Rel-17 | 91 |  |  |
| 1387 | 661.6 | Study on the security of the system enablers for devices having multiple Universal Subscriber Identity Modules (USIM) |  | 266d | 2020-12-04 A | 2021-12-10 A | 100% |  |  | finish no earlier than 2021-12-12 | S3 | 2128h | 2128h | FS_MUSIM_SEC | 46 | Abhijeet Kolekar, Intel Corporation | abhijeet.kolekar@intel.com | Rel-17 | 90 | 33.873 |  |

Notes:
- 1363: 23.501; 23.502; 23.503
- 1364: ; 8/10/19: 23.700-40 added;; 6/12/19: 0%->15; 25/3/20: 15%->35; 26/6/20: FCD:12/03/2020->09/20; 26/6/20: 35%->55; 12/9/20: 55%->75; 12/9/20: FCD:15/09/2020->12/20; 5/12/20: 75%->90; 5/12/20: FCD:15/12/2020->03/20; 19/3/21: 90%->100
- 1365: 23.501; 23.502; 23.503 ; 19/3/21: 0%->5; 14/6/21: 5%->85; 14/6/21: FCD:Fri 11/06/->09/21; 13/9/21: 85%->97; 10/12/21: 97%->99; 22/3/22: 99%->100
- 1366: 1/10/21: WID:CP-210288->CP-211091
- 1367: 11/6/21: 0%->30; 13/9/21: 30%->45; 13/12/21: 45%->80; 12/3/22: 80%->100
- 1368: 11/6/21: 0%->30; 13/9/21: 30%->40; 13/12/21: 40%->80; 12/3/22: 80%->96; 4/6/22: 96%->100
- 1369: 11/6/21: 0%->30; 13/9/21: 30%->45; 1/10/21: WID:CP-210288->CP-211091; 13/12/21: 45%->80; 12/3/22: 80%->100
- 1370: tested: SA/CT REL-17 WI eNS_Ph2 (note: This WI is not testing NR_slice-Core) 6/6/22: Compl:0%->10% ; ; 20/6/22: Rapporteur: CMCC->Luting Kong, Xiaozhong Chen, CMCC, CATT; Rap eMail: ->kongluting@chinamobile.com, chenxiaozhong@catt.cn ; ;...; 9/12/22:...; ; ; ; ; ; ; ; ; ; ; ; ; ; ; ; ; ; ; ; ; 7/6/23: Compl:87%->100%
- 1371: follow-up WI of RAN2 REL-17 SI FS_NR_slice; no Perf. part ; 2/7/21: WID:RP-210912->RP-211290; 29/9/21: WID:RP-211290->RP-212534; 12/7/22: WID:RP-212534->RP-221377
- 1372: follow-up WI of RAN2 REL-17 SI FS_NR_slice; no Perf. part ; 20/6/22: FCD:12/03/2022->22/06/2022; Compl:0%->100%; Stat Rep: ->RP-221375; Rapporteur: CMCC->Ningyu Chen, CMCC; Rap eMail: ->chenningyu@chinamobile.com;
- 1373: 9/9/22: Comp...; 23/9/22: WID:RP-221364->RP-222118; 9/12/22: FCD:22/09/2022->01/09/2023; Compl:12%->13%; Stat Rep: ->RP-223068; Rapporteur: CMCC->Danni Song, CMCC; Rap eMail: ->songdan@chinamobile.com; 9/1/23: WID:RP-222118->RP-223067; 17...; 6/9/23: FCD:09/09/2023->22/09/2023; Compl:91%->100%; Stat Rep: RP-230287->RP-232242;
- 1374: ; 4/6/22: 0%->100
- 1375: ; 4/6/22: 0%->100; 3/8/22: 99%->100
- 1376: 13/9/20: 0%->5; 13/9/20: WID:SP-191192->SP-200766; 5/12/20: 5%->20; 21/3/21: 20%->40; 11/6/21: 40%->80; 11/6/21: FCD:Fri 11/06/->09/21; 13/9/21: 80%->90; 13/9/21: FCD:Wed 08/09/->12/21; 13/12/21: 90%->100
- 1377: ; 12/3/22: 0%->100
- 1380: 14/3/19: 0%->5; 31/5/19: 5%->95; 13/9/19: 95%->98; 6/12/19: 98%->100
- 1381: 13/9/19: 0%->50; 6/12/19: 50%->100
- 1382: 21/3/19: WID:SP-181251->SP-190248; 6/12/19: 0%->29; 25/3/20: WID:SP-190248->SP-200297; 25/3/20: 29%->45; 26/6/20: FCD:11/06/2020->09/20; 26/6/20: 45%->60; 12/9/20: 60%->80; 12/9/20: FCD:15/09/2020->12/20; 5/12/20: 80%->90; 5/12/20: FCD:15/12/2020->03/2
- 1383: 23.501; 23.502; 23.401; 23.228 ; 19/3/21: 0%->20; 13/6/21: WID:SP-200978->SP-210091; 14/6/21: 20%->90; 14/6/21: FCD:Fri 11/06/->09/21; 13/9/21: 90%->98; 10/12/21: 98%->100
- 1384: ; 10/9/21: WID:CP-210280->CP-212102; 01/22: rapporteur changed from Vivek Gupta
- 1385: ; 11/6/21: 0%->40; 13/9/21: 40%->65; 13/12/21: 65%->90; 12/3/22: 90%->100
- 1386: ; 11/6/21: 0%->40; 13/12/21: 40%->90; 12/3/22: 90%->100
- 1387: 5/12/20: 0%->10; 10/2/21: 33.873 added;; 19/3/21: 10%->35; 19/3/21: FCD:12/03/2021->06/21; 11/6/21: 35%->96; 11/6/21: FCD:Fri 11/06/->12/21; 13/9/21: 96%->100

| ID | WBS | Task | Type | Duration | Start | Finish | Complete | Remaining | Total slack | Constraint | Resources | Work | Actual work | Acronym | PCG approved | WI rapporteur name | Release | TSG approved | WI rapporteur e-mail | Status Report | Impacted TSs and TRs |
| --- | --- | --- | --- | --- | --- | --- | --- | --- | --- | --- | --- | --- | --- | --- | --- | --- | --- | --- | --- | --- | --- |
| 1388 | 662 | **Support for Multi-SIM devices for LTE/NR** |  | 992d | 2019-12-09 A | 2023-09-22 A | 100% |  |  |  |  | 7976h | 7976h | LTE_NR_MUSIM | 44 | Vivo | Rel-17 | 86 |  |  |  |
| 1389 | 662.1 | Core part: Support for Multi-SIM devices for LTE/NR |  | 597d | 2019-12-09 A | 2022-03-22 A | 100% |  |  | finish no earlier than 2022-03-22 | R2 | 4776h | 4776h | LTE_NR_MUSIM-Core | 44 | Xiaodong Yang | Rel-17 | 86 | Yangxiaodong5g@vivo.com | RP-220603 |  |
| 1390 | 662.2 | UE Conformance - Multi-SIM devices for LTE/NR |  | 400d | 2022-03-15 A | 2023-09-22 A | 100% |  |  | finish no earlier than 2023-09-22 | R5 | 3200h | 3200h | LTE_NR_MUSIM_plus_CT1-UEConTest | 48 | Jing Zhao, China telecom | Rel-17 | 95 | Zhaoj16@chinatelecom.cn | RP-231824 |  |
| 1391 | 663 | Rel-17 other cross-TSG Features | milestone, manual | 0d | 2016-06-09 A | 2016-06-09 A | 100% |  |  | finish no earlier than 2016-06-09 |  |  |  |  |  |  | Rel-17 |  |  |  | 26.234; 26.247 |
| 1392 | 664 | **Support of the 5GMSG Service** |  | 657d | 2019-06-06 A | 2021-12-10 A | 100% |  |  |  |  | 6288h | 6288h | FS_5GMARCH | 43 | Liu, Yue, China Mobile | Rel-17 | 84 | liuyueyjy@chinamobile.com |  | 23.700-24 |
| 1393 | 664.1 | Study on support of the 5GMSG Service |  | 397d | 2019-06-06 A | 2020-12-11 A | 100% |  |  | finish no earlier than 2020-12-12 | S6 | 3176h | 3176h | FS_5GMARCH | 43 | Liu, Yue, China Mobile | Rel-17 | 84 | liuyueyjy@chinamobile.com |  | 23.700-24 |
| 1394 | 664.2 | Study on security aspects of the 5GMSG Service (St1 in Rel16) |  | 323d | 2020-09-16 A | 2021-12-10 A | 100% |  |  | finish no earlier than 2021-12-12 | S3 | 2584h | 2584h | FS_SEC_5GMSG | 45 | Xiaoting Huang, China Mobile | Rel-17 | 89 | huangxiaoting@chinamobile.com |  | 33.862 |
| 1395 | 664.3 | Security aspects of the 5GMSG Service |  | 66d | 2021-09-10 A | 2021-12-10 A | 100% |  |  | finish no earlier than 2021-12-12 | S3 | 528h | 528h | 5GMSG | 47 | Xiaoting Huang, China Mobile | Rel-17 | 93 | huangxiaoting@chinamobile.com |  | 33.501 |
| 1396 | 665 | **Application Architecture for MSGin5G Service** |  | 389d | 2020-09-16 A | 2022-03-11 A | 100% |  |  |  |  | 4704h | 4704h | 5GMARCH | 45 | Liu, Yue, China Mobile | Rel-17 | 89 | liuyueyjy@chinamobile.com |  | 23.554 |
| 1397 | 665.1 | Application Architecture for MSGin5G Service |  | 195d | 2020-09-16 A | 2021-06-15 A | 100% |  |  | finish no earlier than 2021-06-15 | S6 | 1560h | 1560h | 5GMARCH | 45 | Liu, Yue, China Mobile | Rel-17 | 89 | liuyueyjy@chinamobile.com |  | 23.554 |
| 1398 | 665.2 | **CT aspects for enabling MSGin5G Service** |  | 132d | 2021-09-10 A | 2022-03-11 A | 100% |  |  |  | ct | 3144h | 3144h | 5GMARCH | 47 | Liu, Yue, China Mobile | Rel-17 | 93 | liuyueyjy@chinamobile.com |  | 29.222 |
| 1399 | 665.2.1 | CT1 aspects for enabling MSGin5G Service |  | 131d | 2021-09-10 A | 2022-03-11 A | 100% |  |  | finish no earlier than 2022-03-12 | C1 | 1048h | 1048h | 5GMARCH | 47 | Liu, Yue, China Mobile | Rel-17 | 93 | liuyueyjy@chinamobile.com |  | 24.538 |
| 1400 | 665.2.2 | CT3 aspects for enabling MSGin5G Service |  | 131d | 2021-09-10 A | 2022-03-11 A | 100% |  |  | finish no earlier than 2022-03-12 | C3 | 1048h | 1048h | 5GMARCH | 47 | Liu, Yue, China Mobile | Rel-17 | 93 | liuyueyjy@chinamobile.com |  | 29.538 |
| 1401 | 666 | **IMS voice service support and network usability guarantee for UE s E-UTRA capability disabled scenario in SA 5GS** |  | 706d | 2021-09-29 A | 2024-06-06 | 86% | 96.9d | 453d |  | ct | 9640h | 2832h | ING_5GS | 47 | Mingxue Li, China Telecom | Rel-17 | 93 | limx36@chinatelecom.cn |  |  |
| 1402 | 666.1 | CT1 aspects of ING_5GS |  | 118d | 2021-09-29 A | 2022-03-11 A | 100% |  |  | finish no earlier than 2022-03-12 | C1 | 944h | 944h | ING_5GS | 47 | Mingxue Li, China Telecom | Rel-17 | 93 | limx36@chinatelecom.cn |  | 24.301; 24.368; 24.501 |
| 1403 | 666.2 | CT6 aspects of ING_5GS |  | 118d | 2021-09-29 A | 2022-03-11 A | 100% |  |  | finish no earlier than 2022-03-12 | C6 | 944h | 944h | ING_5GS | 47 | Mingxue Li, China Telecom | Rel-17 | 93 | limx36@chinatelecom.cn |  | 31.102 |
| 1404 | 666.3 | UE Conformance - ING_5GS |  | 264d | 2023-06-08 A | 2024-06-06 | 74% | 68.64d | 453d | finish no earlier than 2024-06-06 | R5 | 2112h |  | ING_5GS-UEConTest | 51 | Jing Zhao, China telecom | Rel-17 | 100 | Zhaoj16@chinatelecom.cn | RP-240115 |  |
| 1405 | 667 | **User Consent for 3GPP services** |  | 453d | 2020-09-16 A | 2022-06-09 A | 100% |  |  |  |  | 5192h | 5192h | UC3S | 45 | Rong Wu, Huawei Technologies | Rel-17 | 89 | raina.wu@huawei.com |  | 33.867 |
| 1406 | 667.1 | Study on User Consent for 3GPP services |  | 453d | 2020-09-16 A | 2022-06-09 A | 100% |  |  | finish no earlier than 2022-06-12 | S3 | 3624h | 3624h | FS_UC3S | 45 | Rong Wu, Huawei Technologies | Rel-17 | 89 | raina.wu@huawei.com |  | 33.867 |
| 1407 | 667.2 | Security aspects on User Consent for 3GPP services |  | 196d | 2021-09-10 A | 2022-06-09 A | 100% |  |  | finish no earlier than 2022-06-12 | S3 | 1568h | 1568h | UC3S_SEC | 47 | Rong Wu, Huawei Technologies | Rel-17 | 93 | Raina.wu@huawei.com |  | 33.501 |
| 1408 | 668 | User Plane Integrity Protection for LTE |  | 192d | 2021-03-18 A | 2021-12-10 A | 100% |  |  | finish no earlier than 2021-12-12 | S3 | 1536h | 1536h | UPIP_SEC_LTE | 46 | Evans, Tim, Vodafone | Rel-17 | 91 | tim.evans1@vodafone.com |  | 33.401; 33.501 |
| 1409 | 669 | **User Plane Integrity Protection support for EPC connected architectures** |  | 581d | 2021-12-13 A | 2024-03-01 | 99% | 0d | 0d |  | R3 | 8328h | 4256h | UPIP_SEC_LTE-RAN | 48 | Vodafone | Rel-17 | 94 |  |  |  |
| 1410 | 669.1 | Core part: User Plane Integrity Protection support for EPC connected architectures |  | 72d | 2021-12-13 A | 2022-03-22 A | 100% |  |  | start no earlier than 2021-12-12 | R3 | 576h | 576h | UPIP_SEC_LTE-RAN-Core | 48 | Vodafone | Rel-17 | 94 |  |  |  |
| 1411 | 669.2 | UE Conformance - User Plane Integrity Protection support for EPC connected architectures (incl. CT/SA aspects) |  | 388d | 2022-09-08 A | 2024-03-01 A | 100% |  |  | finish no earlier than 2024-03-01 | R5 | 3104h | 3104h | UPIP_SEC_LTE-RAN-UEConTest | 49 | Petra RAUER, Vodafone | Rel-17 | 97 | Petra[dot]Rauer[at]Vodafone[dot]com | RP-240047 |  |
| 1412 | 670 | Start of Pause of Charging via User Plane |  | 62d | 2021-03-18 A | 2021-06-11 A | 100% |  |  | finish no earlier than 2021-06-12 | C4 | 496h | 496h | SPOCUP | 46 | YONG, YANG, Ericsson, frank | Rel-17 | 91 | yong.yang@ericsson.com |  | 29.244; 29.060; 29.281; 29.274; 29.502 |
| 1413 | 671 | NPN support of PWS | milestone | 0d | 2021-06-12 A | 2021-06-12 A | 100% |  |  | finish no earlier than 2021-06-12 | S1 |  |  | NPN_PWS | 47 | Francesco Pica, Qualcomm | Rel-17 | 92 | fpica <at> qti.qualcomm.com |  | 22.261 |

Notes:
- 1388: 28/7/20: WID:RP-193263->RP-201309. 6/1/21: WID:RP-193263->RP-202895; 7/4/21: WID:RP-202895->RP-210316; 2/7/21: WID:RP-210316->RP-211561; 29/9/21: WID:RP-211561->RP-212610; 6/1/22: WID:RP-212610->RP-213679
- 1389: 20/6/22: FCD:17/06/2021->22/03/2023; Compl:0%->100%; Stat Rep: ->RP-220603; Rapporteur: Vivo->Xiaodong Yang; Rap eMail: ->Yangxiaodong5g@vivo.com20/6/22: 0%->100
- 1390: tested: REL-17 WI LTE_NR_MUSIM-Core and REL-17 CT1 WI MUSIM 6/6/22: Compl:0%->5% 6/6/ ; 20/6/22: Rapporteur: China Telecom->Jing Zhao, China telecom; Rap eMail: ->Zhaoj16@chinatelecom.cn12/7/22: WID:RP-220127->RP-221193; 23/9/22: 5%->25; 23/9/22: FCD:...; 6/9/23: FCD:09/09/2023->22/09/2023; Compl:99%->100%; Stat Rep: RP-230076->RP-231824;
- 1392: 13/9/19: 0%->20; 8/10/19: 23.700-24 added;; 6/12/19: 20%->35; 26/3/20: 35%->40; 28/6/20: 40%->50; 13/9/20: 50%->65; 13/9/20: WID:SP-190559->SP-200835; 13/9/20: FCD:12/06/2020->12/20; 5/12/20: 65%->80; 21/3/21: 80%->95; 11/6/21: 95%->100
- 1393: 13/9/19: 0%->20; 8/10/19: 23.700-24 added;; 6/12/19: 20%->35; 26/3/20: 35%->40; 28/6/20: 40%->50; 13/9/20: 50%->65; 13/9/20: WID:SP-190559->SP-200835; 13/9/20: FCD:12/06/2020->12/20; 5/12/20: 65%->80; 21/3/21: 80%->95; 11/6/21: 95%->100
- 1394: 25/9/20: WID:SP-200717->SP-200878; 5/12/20: 0%->10; 19/3/21: 10%->40; 11/6/21: 40%->45; 11/6/21: FCD:Fri 11/06/->12/21; 13/9/21: 45%->75; 12/3/22: 75%->100
- 1395: ; 12/3/22: 0%->100
- 1396: Stage 1 in Rel-16, UID 810014
- 1397: 25/9/20: 23.554 added;; 5/12/20: 0%->5; 10/2/21: FCD:12/03/2021->06/21; 21/3/21: 5%->25; 11/6/21: 25%->75; 13/9/21: 75%->90; 13/12/21: 90%->100
- 1399: ; 1/10/21: 24.538 added;; 13/12/21: 0%->30; 12/3/22: 30%->75; 4/6/22: 75%->100
- 1400: ; 1/10/21: 29.538 added;; 13/12/21: 0%->30; 12/3/22: 30%->100
- 1402: 13/12/21: 0%->85; 12/3/22: 85%->100
- 1403: 12/3/22: 0%->100; 4/6/22: 100%->
- 1404: 6/9/23: FCD:06/06/2024->03/03/2024; Compl:0%->5%; Stat Rep: ->RP-231826; Rapporteur: China Telecom->Jing Zhao, China telecom; Rap eMail: ->Zhaoj16@chinatelecom.cn; ; 14/3/24: FCD:03/03/2024->06/06/2024; Compl:5%->74%; Stat Rep: RP-231826->RP-240115; ; 2/4/24: WID:RP-230873->RP-240049
- 1405: 5/12/20: 0%->5; 19/3/21: 5%->40; 19/3/21: FCD:12/03/2021->06/21; 11/6/21: 40%->50; 11/6/21: FCD:Fri 11/06/->12/21
- 1406: 5/12/20: 0%->5; 19/3/21: 5%->40; 19/3/21: FCD:12/03/2021->06/21; 11/6/21: 40%->50; 11/6/21: FCD:Fri 11/06/->12/21; 13/9/21: 50%->80; 12/3/22: 80%->95; 12/3/22: FCD:10/12/2021->6/22; 31/3/23: 95%->100
- 1407: ; 13/12/21: 0%->85; 12/3/22: 85%->95; 12/3/22: FCD:10/12/2021->6/22; 31/3/23: 95%->100
- 1408: ; 11/6/21: 0%->85; 11/6/21: FCD:Fri 11/06/->12/21; 13/12/21: 85%->100
- 1409: no Perf. part; UPIP_SEC_LTE is an SA3 REL-17 WI; WI is addressing LTE and LTE link in EN-DC case; 29/3/23: WID:RP-213669->RP-230070
- 1410: no Perf. part; UPIP_SEC_LTE is an SA3 REL-17 WI; WI is addressing LTE and LTE link in EN-DC case; 4/6/22: 0%->100
- 1411: 17/3/23: FCD:09/09/2023->08/09/2023; Compl:0%->5%; Stat Rep: ->RP-230071; Rapporteur: Vodafone->Petra RAUER, Vodafone; Rap eMail: ->Petra[dot]Rauer[at]Vodafone[dot]com; ...; 6/9/23: FCD:09/09/2023->12/12/2023; Compl:28%->62%; Stat Rep: RP-230071->RP-2...; 2/4/24: WID:RP-230070->RP-240048
- 1412: ; 21/3/21: 0%->85; 11/6/21: 85%->100
- 1413: 11/3/22: 0%->100

| ID | WBS | Task | Duration | Start | Finish | Complete | Remaining | Total slack | Constraint | Resources | Work | Actual work | Acronym | PCG approved | WI rapporteur name | WI rapporteur e-mail | Release | TSG approved |
| --- | --- | --- | --- | --- | --- | --- | --- | --- | --- | --- | --- | --- | --- | --- | --- | --- | --- | --- |
| 1414 | 672 | **Enhancements of 3GPP profiles for cryptographic algorithms and security protocols** | 258d | 2021-03-18 A | 2022-03-11 A | 100% |  |  |  |  | 3120h | 3120h | eCryptPr | 46 | Pinar Comak, Ericsson | pinar.comak@ericsson.com | Rel-17 | 91 |
| 1415 | 672.1 | Stage 2 for eCryptPr | 192d | 2021-03-18 A | 2021-12-10 A | 100% |  |  | finish no earlier than 2021-12-12 | S3 | 1536h | 1536h | eCryptPr | 46 | Pinar Comak, Ericsson | pinar.comak@ericsson.com | Rel-17 | 91 |
| 1416 | 672.2 | Stage 3 CT1 for eCryptPr | 66d | 2021-12-10 A | 2022-03-11 A | 100% |  |  | finish no earlier than 2022-03-12 | C1 | 528h | 528h | eCryptPr | 48 | Biondic, Nevenka, Ericsson | nevenka.biondic@ericsson.com | Rel-17 | 94 |
| 1417 | 672.3 | Stage 3 CT3 for eCryptPr | 66d | 2021-12-10 A | 2022-03-11 A | 100% |  |  | finish no earlier than 2022-03-12 | C3 | 528h | 528h | eCryptPr | 48 | Biondic, Nevenka, Ericsson | nevenka.biondic@ericsson.com | Rel-17 | 94 |
| 1418 | 672.4 | Stage 3 CT4 for eCryptPr | 66d | 2021-12-10 A | 2022-03-11 A | 100% |  |  | finish no earlier than 2022-03-12 | C4 | 528h | 528h | eCryptPr | 48 | Biondic, Nevenka, Ericsson | nevenka.biondic@ericsson.com | Rel-17 | 94 |
| 1419 | 673 | **AKMA TLS protocol profiles** | 262d | 2021-06-11 A | 2022-06-10 A | 100% |  |  |  | S3 | 4192h | 4192h | AKMA_TLS | 47 | Escott, Adrian, Qualcomm Incorporated | aescott@qti.qualcomm.com | Rel-17 | 92 |
| 1420 | 673.1 | Security aspects of AKMA_TLS | 261d | 2021-06-11 A | 2022-06-10 A | 100% |  |  | finish no earlier than 2022-06-12 | S3 | 2088h | 2088h | AKMA_TLS | 47 | Escott, Adrian, Qualcomm Incorporated | aescott@qti.qualcomm.com | Rel-17 | 92 |
| 1421 | 673.2 | CT aspects of AKMA_TLS | 2d | 2022-03-10 A | 2022-03-11 A | 100% |  |  | finish no earlier than 2022-03-12 | C1 | 16h | 16h | AKMA_TLS | 48 | Chaponniere, Lena, Qualcomm Incorporated | lguellec@qti.qualcomm.com | Rel-17 | 95 |
| 1422 | 674 | Restoration of PDN Connections in PGW-C/SMF Set | 10d | 2020-12-07 A | 2020-12-18 A | 100% |  |  | finish no earlier than 2020-12-18 | C4 | 80h | 80h | RPCPSET | 46 | LANDAIS, Bruno, Nokia | bruno.landais@nokia.com | Rel-17 | 90 |
| 1423 | 675 | Enhancement of Inter-PLMN Roaming | 330d | 2020-12-07 A | 2022-03-11 A | 100% |  |  | finish no earlier than 2022-03-12 | C4 | 2640h | 2640h | EoIPR | 46 | Caixia Qi, Huawei | Caixia.qi@huawei.com | Rel-17 | 90 |
| 1424 | 676 | **Reliable Data Service Serialization Indication** | 657d | 2019-03-07 A | 2021-09-10 A | 100% |  |  |  |  | 15936h | 15936h | RDSSI | 43 | Starsinic, Michael, Convida Wireless LLC | starsinic.michael@convidawireless.com | Rel-17 | 84 |
| 1425 | 676.1 | Stage 2 of RDSSI | 21d | 2019-05-09 A | 2019-06-06 A | 100% |  |  | finish no earlier than 2019-06-06 | S2 | 168h | 168h | RDSSI | 43 | Starsinic, Michael, Convida Wireless LLC | starsinic.michael@convidawireless.com | Rel-17 | 84 |
| 1426 | 676.2 | **CT aspects of RDSSI** | 657d | 2019-03-07 A | 2021-09-10 A | 100% |  |  |  | C1 | 15768h | 15768h | RDSSI | 46 | Vivek Gupta, Intel | vivek.g.gupta@intel.com | Rel-17 | 90 |
| 1427 | 676.2.1 | CT1 aspects of RDSSI | 657d | 2019-03-07 A | 2021-09-10 A | 100% |  |  | finish no earlier than 2021-09-10 | C1 | 5256h | 5256h | RDSSI | 49 | Vivek Gupta, Intel | vivek.g.gupta@intel.com | Rel-17 | 97 |
| 1428 | 676.2.2 | CT3 aspects of RDSSI | 657d | 2019-03-07 A | 2021-09-10 A | 100% |  |  | finish no earlier than 2021-09-10 | C3 | 5256h | 5256h | RDSSI | 49 | Vivek Gupta, Intel | vivek.g.gupta@intel.com | Rel-17 | 97 |
| 1429 | 677 | Adapting BEST for use in 5G networks | 266d | 2020-12-04 A | 2021-12-10 A | 100% |  |  | finish no earlier than 2021-12-12 | S3 | 2128h | 2128h | BEST_5G | 46 | Keesmaat, Iko, KPN | iko.keesmaat@tno.nl | Rel-17 | 90 |
| 1430 | 678 | **Enhanced Service Enabler Architecture Layer for Verticals** | 332d | 2020-12-04 A | 2022-03-11 A | 100% |  |  |  |  | 4248h | 4248h | eSEAL | 47 | Basavaraj (Basu) Pattan, Samsung | basavarajjp@samsung.com | Rel-17 | 92 |
| 1431 | 678.1 | Stage 2 of eSEAL | 138d | 2020-12-04 A | 2021-06-15 A | 100% |  |  | finish no earlier than 2021-06-15 | S6 | 1104h | 1104h | eSEAL | 46 | Basavaraj (Basu) Pattan, Samsung | basavarajjp@samsung.com | Rel-17 | 90 |
| 1432 | 678.2 | CT1 aspects of eSEAL | 196d | 2021-06-11 A | 2022-03-11 A | 100% |  |  | finish no earlier than 2022-03-12 | C1 | 1568h | 1568h | eSEAL | 47 | Sapan Shah (Samsung Electronics) | sapan.shah@samsung.com | Rel-17 | 92 |
| 1433 | 678.3 | CT3 aspects of eSEAL | 196d | 2021-06-11 A | 2022-03-11 A | 100% |  |  | finish no earlier than 2022-03-12 | C3 | 1568h | 1568h | eSEAL | 47 | Sapan Shah (Samsung Electronics) | sapan.shah@samsung.com | Rel-17 | 92 |
| 1434 | 678.4 | Security for eSEAL | 1d | 2021-12-10 A | 2021-12-10 A | 100% |  |  | finish no earlier than 2021-12-12 | S3 | 8h | 8h | eSEAL | 48 | Rajavelsamy Rajadurai, Samsung | rajvel@samsung.com | Rel-17 | 94 |
| 1435 | 679 | **Access Traffic Steering, Switch and Splitting support in the 5G system architecture; Phase 2** | 1442d | 2019-03-07 A | 2024-09-09 | 84% | 231.95d | 386d |  |  | 15136h | 13032h | ATSSS_Ph2 | 46 | Apostolis Salkintzis, Lenovo | y1026c@lenovo.com | Rel-17 | 90 |
| 1436 | 679.1 | Study on ATSSS_Ph2 | 464d | 2019-03-07 A | 2020-12-15 A | 100% |  |  | finish no earlier than 2020-12-15 | S2 | 3712h | 3712h | FS_ATSSS_Ph2 | 43 | So, Tricci, ZTE | tso@ztetx.com | Rel-17 | 84 |
| 1437 | 679.2 | Stage 2 of ATSSS_Ph2 | 137d | 2020-12-03 A | 2021-06-11 A | 100% |  |  | finish no earlier than 2021-06-12 | S2 | 1096h | 1096h | ATSSS_Ph2 | 46 | Apostolis Salkintzis, Lenovo | y1026c@lenovo.com | Rel-17 | 90 |

Notes:
- 1414: ; 11/6/21: 0%->35; 11/6/21: FCD:Fri 10/09/->12/21; 13/9/21: 35%->85 / Impacted TSs and TRs: 33.141; 33.203; 33.210; 33.220; 33.222; 33.310; 33.328; 33.501
- 1415: ; 11/6/21: 0%->35; 11/6/21: FCD:Fri 10/09/->12/21; 13/9/21: 35%->85; 13/12/21: 85%->95; 12/3/22: 95%->100 / Impacted TSs and TRs: 33.141; 33.203; 33.210; 33.220; 33.222; 33.310; 33.328; 33.501
- 1416: ; 12/3/22: 0%->97; 4/6/22: 97%->100 / Impacted TSs and TRs: 24.109; 24.141; 24.229; 24.259; 24.424; 24.481; 24.482; 24.486; 24.545; 24.547; 24.548; 24.623
- 1417: ; 12/3/22: 0%->100 / Impacted TSs and TRs: 29.079; 29.116; 29.122; 29.155; 29.201; 29.222; 29.486; 29.517; 29.522; 29.549
- 1418: ; 7/1/22: 0%->60; 12/3/22: 60%->90; 4/6/22: 90%->100 / Impacted TSs and TRs: 23.008; 29.228; 29.229; 29.240; 23.333; 23.334; 29.334; 29.335
- 1419: ; 13/12/21: 0%->95; 13/12/21: FCD:Fri 10/09/->12/21; 4/6/22: 95%->100; 12/9/22: 100%-> / Impacted TSs and TRs: 33.535
- 1420: ; 13/12/21: 0%->95; 13/12/21: FCD:Fri 10/09/->12/21; 12/3/22: FCD:15/12/2021->6/22; 4/6/22: 100%->100 / Impacted TSs and TRs: 33.535
- 1421: ; 12/3/22: 0%->80; 4/6/22: 100%->100 / Impacted TSs and TRs: 24.109
- 1422: 23.007; 29.274; 29.303; 23.003 ; 5/12/20: 0%->100; 5/12/20: 0%->100
- 1423: 29.510; 29.531; 29.573 ; 21/3/21: 0%->30; 11/6/21: 30%->35; 13/12/21: 35%->80; 13/12/21: FCD:Fri 10/09/->03/22; 12/3/22: 80%->100
- 1424: Impacted TSs and TRs: 23.682; 23.501; 23.502
- 1425: 6/6/19: 0%->100. 9/4/21: Rel-16->Rel-17 / Impacted TSs and TRs: 23.682; 23.501; 23.502
- 1426: 24.250; 29.122 ; 21/3/21: 0%->100
- 1427: 23/9/22: 99%->100
- 1428: 23/9/22: 99%->100
- 1429: 33.163 ; 19/3/21: 0%->40; 11/6/21: 40%->70; 11/6/21: FCD:Fri 11/06/->12/21; 13/9/21: 70%->85; 13/12/21: 85%->100
- 1430: 23.434 ; 5/12/20: 0%->10; 10/2/21: FCD:11/06/2021->06/21; 21/3/21: 10%->35
- 1431: 23.434 ; 5/12/20: 0%->10; 10/2/21: FCD:11/06/2021->06/21; 21/3/21: 10%->35; 11/6/21: 35%->80; 13/9/21: 80%->100
- 1432: ; 2/7/21: 24.549 added;; 10/9/21: WID:CP-211117->CP-212098; 13/9/21: 0%->20; 13/12/21: 20%->60; 12/3/22: 60%->92; 4/6/22: 92%->99 / Impacted TSs and TRs: 29.549;24.548;24.547;24.546;24.545 ; 24.549
- 1433: ; 10/9/21: WID:CP-211117->CP-212098; 13/9/21: 0%->10; 13/12/21: 10%->40; 12/3/22: 40%->96; 4/6/22: 96%->100 / Impacted TSs and TRs: 29.549
- 1434: ; 24/3/22: 0%->100 / Impacted TSs and TRs: 33.434
- 1435: 23.501; 23.502; 23.503
- 1436: 25/3/20: WID:SP-190558->SP-200095; 26/3/20: 0%->15; 26/6/20: FCD:18/06/2020->09/20; 26/6/20: 15%->35; 12/9/20: 35%->70; 12/9/20: FCD:15/09/2020->12/20; 5/12/20: 70%->95; 19/3/21: 95%->100 / Impacted TSs and TRs: New 23.700-93
- 1437: 23.501; 23.502; 23.503 ; 19/3/21: 0%->55; 14/6/21: 55%->97; 13/9/21: 97%->100

| ID | WBS | Task | Duration | Start | Finish | Complete | Total slack | Constraint | Resources | Work | Actual work | Acronym | PCG approved | WI rapporteur name | WI rapporteur e-mail | Release | TSG approved |
| --- | --- | --- | --- | --- | --- | --- | --- | --- | --- | --- | --- | --- | --- | --- | --- | --- | --- |
| 1438 | 679.3 | **CT aspects of ATSSS_Ph2** | 258d | 2021-03-18 A | 2022-03-11 A | 100% |  |  | ct | 8224h | 8224h | ATSSS_Ph2 | 46 | ZHOU Xingyue (Joy), ZTE | zhou.xingyue@zte.com.cn | Rel-17 | 91 |
| 1439 | 679.3.1 | CT1 aspects of ATSSS_Ph2 | 257d | 2021-03-18 A | 2022-03-11 A | 100% |  | finish no earlier than 2022-03-12 | C1 | 2056h | 2056h | ATSSS_Ph2 | 46 | ZHOU Xingyue (Joy), ZTE | zhou.xingyue@zte.com.cn | Rel-17 | 91 |
| 1440 | 679.3.2 | CT3 aspects of ATSSS_Ph2 | 257d | 2021-03-18 A | 2022-03-11 A | 100% |  | finish no earlier than 2022-03-12 | C3 | 2056h | 2056h | ATSSS_Ph2 | 46 | ZHOU Xingyue (Joy), ZTE | zhou.xingyue@zte.com.cn | Rel-17 | 91 |
| 1441 | 679.3.3 | CT4 aspects of ATSSS_Ph2 | 257d | 2021-03-18 A | 2022-03-11 A | 100% |  | finish no earlier than 2022-03-12 | C4 | 2056h | 2056h | ATSSS_Ph2 | 46 | ZHOU Xingyue (Joy), ZTE | zhou.xingyue@zte.com.cn | Rel-17 | 91 |
| 1442 | 679.4 | UE Conformance - ATSSS_Ph2 | 263d | 2023-09-11 | 2024-09-09 |  | 386d | finish no earlier than 2024-09-09 | R5 | 2104h |  | ATSSS_Ph2-UEConTest | 51 | China Telecom |  | Rel-17 | 101 |
| 1443 | 680 | **Enablers for Network Automation for 5G - phase 2** | 723d | 2019-06-06 A | 2022-03-11 A | 100% |  |  |  | 14568h | 14568h | eNA_Ph2 | 46 | TBD |  | Rel-17 | 90 |
| 1444 | 680.1 | Study on Enablers for Network Automation for 5G - phase 2 | 399d | 2019-06-06 A | 2020-12-15 A | 100% |  | finish no earlier than 2020-12-15 | S2 | 3192h | 3192h | FS_eNA_Ph2 | 43 | Xiaobo Wu, Huawei Technologies | wuxiaobo@huawei.com | Rel-17 | 84 |
| 1445 | 680.2 | Study on security aspects of enablers for Network Automation (eNA) for 5GS Phase 2 | 388d | 2020-09-16 A | 2022-03-11 A | 100% |  | finish no earlier than 2022-03-12 | S3 | 3104h | 3104h | FS_eNA_SEC | 45 | Xiaoting Huang, China Mobile | huangxiaoting@chinamobile.com | Rel-17 | 89 |
| 1446 | 680.3 | Stage 2 of eNA_Ph2 | 200d | 2020-12-03 A | 2021-09-08 A | 100% |  | finish no earlier than 2021-09-08 | S2 | 1600h | 1600h | eNA_Ph2 | 46 | TBD |  | Rel-17 | 90 |
| 1447 | 680.4 | **CT aspects of eNA_Ph2** | 257d | 2021-03-19 A | 2022-03-11 A | 100% |  |  | ct | 6144h | 6144h | eNA_Ph2 | 46 | Huang Zhenning (China Mobile) | huangzhenning (at) chinamobile (dot) com | Rel-17 | 91 |
| 1448 | 680.4.1 | CT3 aspects of eNA_Ph2 | 256d | 2021-03-19 A | 2022-03-11 A | 100% |  | finish no earlier than 2022-03-12 | C3 | 2048h | 2048h | eNA_Ph2 | 46 | Huang Zhenning (China Mobile) | huangzhenning (at) chinamobile (dot) com | Rel-17 | 91 |
| 1449 | 680.4.2 | CT4 aspects of eNA_Ph2 | 256d | 2021-03-19 A | 2022-03-11 A | 100% |  | finish no earlier than 2022-03-12 | C4 | 2048h | 2048h | eNA_Ph2 | 46 | Huang Zhenning (China Mobile) | huangzhenning (at) chinamobile (dot) com | Rel-17 | 91 |
| 1450 | 680.5 | Security aspects of eNA_Ph2 | 66d | 2021-09-10 A | 2021-12-10 A | 100% |  | finish no earlier than 2021-12-12 | S3 | 528h | 528h | eNA_Ph2 | 47 | Chang Liu, China Mobile | liuchangyjy@chinamobile.com | Rel-17 | 93 |
| 1451 | 681 | **Proximity based Services in 5GS** | 853d | 2019-03-07 A | 2022-06-10 A | 100% |  |  |  | 25463h | 25463h | 5G_ProSe | 45 | TBD |  | Rel-17 | 88 |
| 1452 | 681.1 | Study on System enhancement for Proximity based Services in 5GS | 526.88d | 2019-03-07 A | 2021-03-12 A | 100% |  | finish no earlier than 2021-03-12 | S2 | 4215h | 4215h | FS_5G_ProSe | 42 | Qiang Deng, CATT | dengqiang1@catt.cn | Rel-17 | 83 |
| 1453 | 681.2 | Stage 2 for Proximity based Services in 5GS | 200d | 2020-12-03 A | 2021-09-08 A | 100% |  | finish no earlier than 2021-09-08 | S2 | 1600h | 1600h | 5G_ProSe | 46 | Qiang Deng, CATT | dengqiang1@catt.cn | Rel-17 | 90 |
| 1454 | 681.3 | **CT aspects of proximity based services in 5GS** | 258d | 2021-03-18 A | 2022-03-11 A | 100% |  |  | ct | 10280h | 10280h | 5G_ProSe | 46 | Yong Jiang, CATT | jiangyong@catt.cn | Rel-17 | 91 |
| 1455 | 681.3.1 | CT1 aspects of 5G_ProSe | 257d | 2021-03-18 A | 2022-03-11 A | 100% |  | finish no earlier than 2022-03-12 | C1 | 2056h | 2056h | 5G_ProSe | 46 | Yong Jiang, CATT | jiangyong@catt.cn | Rel-17 | 91 |
| 1456 | 681.3.2 | CT3 aspects of 5G_ProSe | 257d | 2021-03-18 A | 2022-03-11 A | 100% |  | finish no earlier than 2022-03-12 | C3 | 2056h | 2056h | 5G_ProSe | 46 | Yong Jiang, CATT | jiangyong@catt.cn | Rel-17 | 91 |
| 1457 | 681.3.3 | CT4 aspects of 5G_ProSe | 257d | 2021-03-18 A | 2022-03-11 A | 100% |  | finish no earlier than 2022-03-12 | C4 | 2056h | 2056h | 5G_ProSe | 46 | Yong Jiang, CATT | jiangyong@catt.cn | Rel-17 | 91 |
| 1458 | 681.3.4 | CT6 aspects of 5G_ProSe | 257d | 2021-03-18 A | 2022-03-11 A | 100% |  | finish no earlier than 2022-03-12 | C6 | 2056h | 2056h | 5G_ProSe | 47 | Yong Jiang, CATT | jiangyong@catt.cn | Rel-17 | 92 |
| 1459 | 681.4 | Study on charging aspects of Proximity-based Services in 5GS | 323d | 2020-09-16 A | 2021-12-10 A | 100% |  | finish no earlier than 2021-12-12 | S5 | 2584h | 2584h | FS_5G_Prose_CH | 45 | Shu, Min, CATT | shumin@catt.cn | Rel-17 | 89 |
| 1460 | 681.5 | Charging aspects of Proximity-based Services in 5GS | 131d | 2021-12-10 A | 2022-06-10 A | 100% |  | finish no earlier than 2022-06-12 | S5 | 1048h | 1048h | 5G_ProSe | 48 | Shu, Min, CATT | shumin<at>catt<dot>cn | Rel-17 | 94 |
| 1461 | 681.6 | Study on Security Aspects of Enhancement for Proximity Based Services in 5GS | 521d | 2020-06-12 A | 2022-06-10 A | 100% |  | finish no earlier than 2022-06-12 | S3 | 4168h | 4168h | FS_5G_ProSe_Sec | 45 | Wei Zhou, CATT | zhouwei@catt.cn | Rel-17 | 88 |
| 1462 | 681.7 | Security Aspects of Proximity based Services in 5GS | 196d | 2021-09-10 A | 2022-06-09 A | 100% |  | finish no earlier than 2022-06-12 | S3 | 1568h | 1568h | 5G_ProSe | 47 | Wei Zhou, CATT | zhouwei@catt.cn | Rel-17 | 93 |

Notes:
- 1439: 11/6/21: 0%->60; 13/9/21: 60%->80; 13/12/21: 80%->95; 12/3/22: 95%->96; 4/6/22: 96%->100 / Impacted TSs and TRs: 24.193; 24.301; 24.501
- 1440: 11/6/21: 0%->50; 13/9/21: 50%->80; 13/12/21: 80%->100 / Impacted TSs and TRs: 29.512
- 1441: 11/6/21: 0%->5; 14/6/21: 5%->50; 13/9/21: 50%->60; 13/12/21: 60%->90; 12/3/22: 90%->100 / Impacted TSs and TRs: 29.244; 29.502; 29.518
- 1443: 23.501; 23.502; 23.503; 23.288
- 1444: 8/10/19: 23.700-91 added;; 6/12/19: 0%->15; 25/3/20: WID:SP-190557->SP-200098; 25/3/20: FCD:12/03/2020->06/20; 25/3/20: 15%->32; 26/6/20: FCD:15/06/2020->09/20; 26/6/20: 32%->55; 12/9/20: 55%->70; 12/9/20: FCD:15/09/2020->12/20; 5/12/20: 70%->97; 19/3 / Impacted TSs and TRs: New ; 23.700-91
- 1445: 5/12/20: 0%->10; 19/3/21: 10%->40; 11/6/21: 40%->50; 11/6/21: FCD:Fri 11/06/->12/21; 13/9/21: 50%->75; 12/3/22: 75%->100; 12/3/22: FCD:10/12/2021->3/22 / Impacted TSs and TRs: 33.866
- 1446: 23.501; 23.502; 23.503; 23.288 ; 19/3/21: 0%->40; 14/6/21: 40%->90; 14/6/21: FCD:Fri 11/06/->09/21; 13/9/21: 90%->99; 10/12/21: 99%->100
- 1447: ; 11/6/21: WID:CP-210290->CP-211191 / Impacted TSs and TRs: 29.503; 29.508; 29.510; 29.513; 29.514; 29.517; 29.518; 29.520; 29.522; 29.523; 29.554; 29.571; 29.591
- 1448: ; 11/6/21: 0%->20; 2/7/21: 29.576 added;; 2/7/21: 29.575 added;; 2/7/21: 29.574 added;; 13/9/21: 20%->30; 13/12/21: 30%->65; 13/12/21: WID:CP-211191->CP-213261; 12/3/22: 65%->96; 4/6/22: 96%->100 / Impacted TSs and TRs: 29.576; 29.575; 29.574
- 1449: ; 11/6/21: 0%->5; 14/6/21: 5%->60; 13/9/21: 60%->80; 13/12/21: 80%->90; 12/3/22: 90%->100
- 1450: ; 13/12/21: 0%->90; 12/3/22: 90%->100 / Impacted TSs and TRs: 33.501
- 1452: 7/6/19: WID:SP-190186->SP-190443; 8/10/19: 23.752 added;; 6/12/19: 0%->30; 25/3/20: 30%->55; 26/6/20: FCD:12/06/2020->09/20; 26/6/20: 55%->65; 12/9/20: 65%->70; 12/9/20: FCD:15/09/2020->12/20; 5/12/20: 70%->90; 5/12/20: FCD:15/12/2020->03/20; 19/3/21: / Impacted TSs and TRs: 23.752; 23.752
- 1453: 19/3/21: 0%->30; 11/6/21: 30%->85; 11/6/21: FCD:Fri 11/06/->09/21; 13/9/21: 85%->98; 10/12/21: 98%->99; 12/3/22: 99%->100
- 1454: ; 11/6/21: WID:CP-210292->CP-211110; 10/9/21: WID:CP-211110->CP-212105; 13/7/22: 29.533 added; / Impacted TSs and TRs: 23.122; 24.501; 27.007; 29.513; 29.519; 29.522; 29.525; 23.008; 29.502; 29.503; 29.505; 29.510; 29.518; 29.527; 29.571; 31.102 ; 29.533
- 1455: ; 11/6/21: 0%->50; 13/9/21: 50%->65; 13/12/21: 65%->75; 12/3/22: 75%->85; 4/6/22: 85%->96
- 1456: ; 11/6/21: 0%->35; 2/7/21: 29.557 added;; 13/9/21: 35%->65; 13/12/21: 65%->95; 12/3/22: 95%->100 / Impacted TSs and TRs: 29.557
- 1457: ; 11/6/21: 0%->25; 13/9/21: 25%->45; 13/12/21: 45%->80; 22/3/22: 29.559 added;; 4/6/22: 80%->90 / Impacted TSs and TRs: 29.559
- 1458: 2/7/21: added ; 13/12/21: 0%->50; 12/3/22: 50%->60; 4/6/22: 60%->60
- 1459: 25/9/20: 32.846 added;; 5/12/20: 0%->15; 21/3/21: 15%->40; 13/9/21: 40%->80; 13/9/21: FCD:Wed 08/09/->12/21; 21/6/22: 80%->100 / Impacted TSs and TRs: 32.846
- 1460: ; 12/3/22: 0%->40; 4/6/22: 40%->100 / Impacted TSs and TRs: 32.277; 32.240; 32.290; 32.291; 32.298
- 1461: 28/7/20: 33.847 added;; 12/9/20: 0%->15; 5/12/20: 15%->45; 5/12/20: FCD:15/12/2020->06/20; 19/3/21: 45%->60; 9/4/21: 60%->65; 11/6/21: 65%->75; 11/6/21: FCD:Fri 11/06/->12/21; 13/9/21: 75%->85; 12/3/22: 85%->85; 12/3/22: FCD:10/12/2021->06/22; 4/6/22: / Impacted TSs and TRs: 33.847
- 1462: ; 13/12/21: 0%->45; 13/12/21: FCD:Fri 10/12/->03/22; 12/3/22: 45%->65; 12/3/22: FCD:11/03/2022->6/22; 22/3/22: 33.503 added;; 4/6/22: 65%->92; 12/9/22: 92%->83; 31/3/23: 83%->100 / Impacted TSs and TRs: New ; 33.503

| ID | WBS | Task | Duration | Start | Finish | Complete | Remaining | Total slack | Constraint | Resources | Work | Actual work | Acronym | PCG approved | WI rapporteur name | Release | TSG approved | Impacted TSs and TRs | WI rapporteur e-mail | Status Report | TSG stopped |
| --- | --- | --- | --- | --- | --- | --- | --- | --- | --- | --- | --- | --- | --- | --- | --- | --- | --- | --- | --- | --- | --- |
| 1463 | 682 | **NR Sidelink Relay** | 401d | 2021-03-12 A | 2022-09-22 A | 100% |  |  |  |  | 5344h | 5344h | NR_SL_relay | 46 | OPPO | Rel-17 | 91 |  |  |  |  |
| 1464 | 682.1 | Core part: NR Sidelink Relay | 268d | 2021-03-12 A | 2022-03-22 A | 100% |  |  | finish no earlier than 2022-03-22 | R2 | 2144h | 2144h | NR_SL_relay-Core | 46 | Qianxi Lu, Xueyan Huang | Rel-17 | 91 | 38.351 | qianxi.lu@oppo.com, huangxueyan@chinamoblie.com | RP-220210 |  |
| 1465 | 682.2 | Perf. part: NR Sidelink Relay | 400d | 2021-03-12 A | 2022-09-22 A | 100% |  |  | finish no earlier than 2022-09-22 | R4 | 3200h | 3200h | NR_SL_relay-Perf | 46 | Qianxi Lu, Xueyan Huang, OPPO, CMCC | Rel-17 | 91 |  | qianxi.lu@oppo.com, huangxueyan@chinamoblie.com | RP-221187 / 1770 |  |
| 1466 | 683 | **Authentication and key management for applications based on 3GPP credential in 5G** | 648d | 2019-09-19 A | 2022-03-11 A | 100% |  |  |  |  | 13952h | 13952h | AKMA | 43 | Xiaoting Huang, China Mobile | Rel-17 | 85 | New ; 33.535 | huangxiaoting@chinamobile.com |  |  |
| 1467 | 683.1 | SA3 aspects of AKMA | 192d | 2019-09-19 A | 2020-06-12 A | 100% |  |  | finish no earlier than 2020-06-12 | S3 | 1536h | 1536h | AKMA | 43 | Xiaoting Huang, China Mobile | Rel-17 | 85 | New ; 33.535 | huangxiaoting@chinamobile.com |  |  |
| 1468 | 683.2 | **CT aspects of AKMA** | 389d | 2020-09-16 A | 2022-03-11 A | 100% |  |  |  | ct | 12416h | 12416h | AKMA-CT | 45 | Huang Zhenning (China Mobile) | Rel-17 | 89 |  | huangzhenning (at) chinamobile (dot) com |  |  |
| 1469 | 683.2.1 | CT1 aspects of AKMA | 388d | 2020-09-16 A | 2022-03-11 A | 100% |  |  | finish no earlier than 2022-03-12 | C1 | 3104h | 3104h | AKMA-CT | 45 | Huang Zhenning (China Mobile) | Rel-17 | 89 | 24.501 | huangzhenning (at) chinamobile (dot) com |  |  |
| 1470 | 683.2.2 | CT3 aspects of AKMA | 388d | 2020-09-16 A | 2022-03-11 A | 100% |  |  | finish no earlier than 2022-03-12 | C3 | 3104h | 3104h | AKMA-CT | 45 | Huang Zhenning (China Mobile) | Rel-17 | 89 | 29.522 | huangzhenning (at) chinamobile (dot) com |  |  |
| 1471 | 683.2.3 | CT4 aspects of AKMA | 388d | 2020-09-16 A | 2022-03-11 A | 100% |  |  | finish no earlier than 2022-03-12 | C4 | 3104h | 3104h | AKMA-CT | 45 | Huang Zhenning (China Mobile) | Rel-17 | 89 | 29.503; 29.510; 29.571 | huangzhenning (at) chinamobile (dot) com |  |  |
| 1472 | 684 | **Enhancement of Private Network support for NG-RAN** | 975d | 2020-09-17 A | 2024-06-06 | 79% | 206.82d | 453d |  | R3 | 15048h | 6248h | NG_RAN_PRN_enh | 45 | China Telecom | Rel-17 | 89 |  |  |  |  |
| 1473 | 684.1 | Core part: Enhancement of Private Network support for NG-RAN | 387d | 2020-09-17 A | 2022-03-11 A | 100% |  |  | finish no earlier than 2022-03-22 | R3 | 3096h | 3096h | NG_RAN_PRN_enh-Core | 45 | China Telecom | Rel-17 | 89 |  |  | RP-220561 |  |
| 1474 | 684.2 | UE Conformance - Enhancement of Private Network support for NG-RAN including CT aspects | 520d | 2022-06-15 A | 2024-06-06 | 63% | 192.4d | 453d | finish no earlier than 2024-06-06 | R5 | 4160h |  | NG_RAN_PRN_enh_plus_CT-UEConTest | 49 | Lei GAO, Yogesh Tugnawat, China Telecom, Qualcomm | Rel-17 | 96 |  | gaol8@chinatelecom.cn, yogesht@qti.qualcomm.com | RP-240358 |  |
| 1475 | 685 | **Multimedia Priority Service (MPS) Phase 2** | 1107d? | 2017-12-15 A | 2022-03-11 A | 100% |  |  |  |  | 23112h | 23112h | MPS2 | 43 | Singh, Ray P; Perspecta Labs | Rel-17 | 84 | 22.953; 22.153 | rsingh@perspectalabs.com |  |  |
| 1476 | 685.1 | Study on MPS2 | 455d? | 2017-12-15 A | 2019-09-12 A | 100% |  |  | finish no earlier than 2019-09-12 | S1 | 3640h | 3640h | FS_MPS2 | 40 | Singh, Ray P; Vencore Labs | Rel-17 | 78 | 22.854 | rsingh@vencorelabs.com |  |  |
| 1477 | 685.2 | Stopped - Study on MPS2, Stage 2 | 192d | 2019-09-19 A | 2020-06-12 A | 100% |  |  | finish no earlier than 2020-06-12 | S2 | 1536h | 1536h | FS_MPS2_St2 | 43 | Don Lukacs; Perspecta Labs | Rel-17 | 85 | New ; 23.775 | dlukacs@perspectalabs.com |  | 96 |
| 1478 | 685.3 | Stage 1 of MPS2 | 136d | 2019-06-06 A | 2019-12-12 A | 100% |  |  | finish no earlier than 2019-12-12 | S1 | 1088h | 1088h | MPS2 | 43 | Singh, Ray P; Perspecta Labs | Rel-17 | 84 | 22.953; 22.153 | rsingh@perspectalabs.com |  |  |
| 1479 | 685.4 | Stage 2 of MPS2 | 318d | 2020-03-25 A | 2021-06-11 A | 100% |  |  | finish no earlier than 2021-06-12 | S2 | 2544h | 2544h | MPS2 | 44 | Streijl, Robert, Perspecta Labs | Rel-17 | 87 |  | rstreijl@perspectalabs.com |  |  |
| 1480 | 685.5 | **Stage 3 of MPS2** | 448d | 2020-06-25 A | 2022-03-11 A | 100% |  |  |  | ct | 14304h | 14304h | MPS2 | 45 | Peter Monnes, Perspecta Labs | Rel-17 | 88 |  | pmonnes@perspectalabs.com |  |  |
| 1481 | 685.5.1 | CT1 aspects of MPS2 | 447d | 2020-06-25 A | 2022-03-11 A | 100% |  |  | finish no earlier than 2022-03-12 | C1 | 3576h | 3576h | MPS2 | 45 | Peter Monnes, Perspecta Labs | Rel-17 | 88 |  | pmonnes@perspectalabs.com |  |  |
| 1482 | 685.5.2 | CT3 aspects of MPS2 | 447d | 2020-06-25 A | 2022-03-11 A | 100% |  |  | finish no earlier than 2022-03-12 | C3 | 3576h | 3576h | MPS2 | 45 | Peter Monnes, Perspecta Labs | Rel-17 | 88 |  | pmonnes@perspectalabs.com |  |  |
| 1483 | 685.5.3 | CT4 aspects of MPS2 | 447d | 2020-06-25 A | 2022-03-11 A | 100% |  |  | finish no earlier than 2022-03-12 | C4 | 3576h | 3576h | MPS2 | 45 | Peter Monnes, Perspecta Labs | Rel-17 | 88 |  | pmonnes@perspectalabs.com |  |  |
| 1484 | 686 | Mission critical security enhancements phase 2 | 323d | 2020-09-16 A | 2021-12-10 A | 100% |  |  | finish no earlier than 2021-12-12 | S3 | 2584h | 2584h | MCXSec2 | 45 | Woodward, Tim, Motorola Solutions, Inc, | Rel-17 | 89 | 33.180 | tim.woodward@motorolasolutions.com |  |  |
| 1485 | 687 | **PAP/CHAP protocols usage in 5GS** | 258d | 2020-09-16 A | 2021-09-10 A | 100% |  |  |  | ct | 5152h | 5152h | PAP_CHAP | 45 | Mingxue Li, China Telecom | Rel-17 | 89 |  | limx36@chinatelecom.cn |  |  |
| 1486 | 687.1 | CT1 aspects of PAP/CHAP protocols usage in 5GS | 258d | 2020-09-16 A | 2021-09-10 A | 100% |  |  | finish no earlier than 2021-09-12 | C1 | 2064h | 2064h | PAP_CHAP | 45 | Mingxue Li, China Telecom | Rel-17 | 89 |  | limx36@chinatelecom.cn |  |  |
| 1487 | 687.2 | CT3 aspects of PAP/CHAP protocols usage in 5GS | 128d | 2020-09-16 A | 2021-03-12 A | 100% |  |  | finish no earlier than 2021-03-12 | C3 | 1024h | 1024h | PAP_CHAP | 45 | Mingxue Li, China Telecom | Rel-17 | 89 |  | limx36@chinatelecom.cn |  |  |

Notes:
- 1463: follow-up WI of RAN2 REL-17 SI FS_NR_SL_relay ; 2/7/21: WID:RP-210904->RP-211050; 29/9/21: WID:RP-211050->RP-212601
- 1464: follow-up WI of RAN2 REL-17 SI FS_NR_SL_relay ; 2/7/21: 38.351 added;; 20/6/22: FCD:12/03/2022->22/03/2022; Compl:0%->100%; WID: RP-211050->RP-212819; Stat Rep: ->RP-220210; Rapporteur: OPPO->Qianxi Lu, Xueyan Huang; Rap eMail: ->qianxi.lu@oppo.com, huangxueyan@chinamoblie.com;
- 1465: follow-up WI of RAN2 REL-17 SI FS_NR_SL_relay ; 13/9/21: Compl:0%->55%; 13/9/21: CD:Thu 08/09/22->Tue 22/03/22; 13/9/21: Stat Rep: ->RP-211779 20/6/22: FCD:22/03/2022->22/09/2022; Compl:100%->95%; Stat Rep: RP-220210->RP-221187 / 1770; Rapporteur:...
- 1466: ; 8/10/19: 33.535 added; 6/12/19: 0%->20; 25/3/20: 20%->60; 25/3/20: FCD:12/03/2020->06/20; 26/6/20: 60%->95; 25/09/20: Rel-16->Rel-17
- 1467: ; 8/10/19: 33.535 added; 6/12/19: 0%->20; 25/3/20: 20%->60; 25/3/20: FCD:12/03/2020->06/20; 26/6/20: 60%->95; 12/9/20: 95%->96; 25/09/20: Rel-16->Rel-17; 5/12/20: 96%->97; 19/3/21: 97%->98; 12/3/22: 98%->100
- 1468: 25/9/20: WID:CP-202047->CP-202240; 25/9/20: WID:CP-202240->CP-202254
- 1469: 21/3/21: 0%->95; 13/9/21: 95%->96; 13/12/21: 96%->97; 12/3/22: FCD:12/03/2021->3/22; 12/3/22: 97%->100
- 1470: 5/12/20: 0%->15; 21/3/21: 15%->95; 11/6/21: 95%->97; 13/9/21: 97%->95; 13/9/21: FCD:Fri 12/03/->03/22; 13/12/21: 95%->99; 12/3/22: 99%->100
- 1471: 13/9/20: FCD:12/03/2021->09/21; 5/12/20: 0%->20; 21/3/21: 20%->95; 13/9/21: FCD:Wed 08/09/->03/22; 12/3/22: 95%->100
- 1472: follow-up WI of REL-16 WI NG_RAN_PRN-Core which was completed in June 20; no Perf. part; related SA2 SI? ; 6/1/21: WID:RP-202051->RP-202363; 29/9/21: WID:RP-202363->RP-212585
- 1473: follow-up WI of REL-16 WI NG_RAN_PRN-Core which was completed in June 20; no Perf. part; related SA2 SI? ; 13/9/21: Compl:0%->50%; 13/9/21: CD:Thu 17/06/21->Tue 22/03/22; 13/9/21: ;
- 1474: 9/9/22: Comp...; 9/12/22: FCD:23/12/2022->01/12/2023; Stat Rep: ->RP-222942; Rapporteur: ChinaTelecom->Lei GAO, Yogesh Tugnawat, China Telecom, Qualcomm; Rap eMail: ->gaol8@chinatelecom.cn, yogesht@qti.qualcomm.com; 17/3/23: FCD:30/11/202.....; 14/3/24: FCD:05/06/2024->06/06/2024; Compl:54%->63%; Stat Rep: RP-233564->RP-240358;
- 1476: 16/3/18: 0%->10¦7/6/18: 10%->30¦10/9/18: 30%->50¦4/12/18: 50%->65¦12/12/18: FCD:03/19->09/19. Rel-16->Rel-17¦14/3/19: 65%->80; 31/5/19: 80%->90; 7/6/19: WID:SP-170996->SP-190315; 17/8/20: 90%->100
- 1477: ; 8/10/19: 23.775 added;; 22/3/22: 0%->100. Puneet: finally no study phase needed.
- 1478: 13/9/19: 0%->85; 6/12/19: 85%->100
- 1479: 25/9/20: WID:SP-200083->SP-200519; 5/12/20: FCD:16/12/2020->06/20; 5/12/20: 0%->20; 19/3/21: 20%->98; 11/6/21: 98%->99; 12/3/22: 99%->100
- 1480: 24.229; 29.212; 29.213; 29.214; 29.512; 29.513; 29.514; 29.328
- 1481: 24.229; 2/7/20: FCD:16/12/2020->03/21; 13/9/20: 0%->50; 5/12/20: 50%->75; 21/3/21: 75%->80; 13/9/21: 80%->90; 13/12/21: 90%->95; 12/3/22: FCD:15/03/2021->3/22; 12/3/22: 95%->100
- 1482: 29.212; 29.213; 29.214; 29.512; 29.513; 29.514; 2/7/20: FCD:20/09/2021->03/21; 11/6/21: 0%->70; 13/9/21: 70%->95; 12/3/22: FCD:15/03/2021->3/22; 12/3/22: 95%->100
- 1483: 29.328 ; 2/7/20: FCD:20/09/2021->03/21; 11/6/21: 0%->70; 13/9/21: FCD:Mon 15/03/->03/22; 7/1/22: 70%->95; 12/3/22: 95%->100
- 1484: ; 12/9/20: FCD:12/03/2021->06/21; 12/9/20: 0%->10; 25/9/20: WID:SP-200718->SP-200879; 5/12/20: 10%->100; 19/3/21: 100%->25; 11/6/21: 25%->80; 11/6/21: FCD:Fri 11/06/->12/21; 13/9/21: 80%->82; 13/12/21: 82%->100
- 1485: 24.501; 29.561 ; 12/3/22: 99%->100
- 1486: 24.501; 5/12/20: 0%->90; 5/12/20: FCD:12/03/2021->09/20; 21/3/21: 90%->95; 11/6/21: 95%->100
- 1487: 29.561; 5/12/20: 0%->75; 21/3/21: 75%->95; 21/3/21: WID:CP-202251->CP-210188; 11/6/21: 95%->100

| ID | WBS | Task | Duration | Start | Finish | Complete | Constraint | Resources | Work | Actual work | Acronym | PCG approved | WI rapporteur name | WI rapporteur e-mail | Release | TSG approved | Impacted TSs and TRs | Status Report | TSG stopped |
| --- | --- | --- | --- | --- | --- | --- | --- | --- | --- | --- | --- | --- | --- | --- | --- | --- | --- | --- | --- |
| 1488 | 688 | **Service-based support for SMS in 5GC** | 389d | 2020-09-16 A | 2022-03-11 A | 100% |  |  | 6208h | 6208h | SMS_SBI | 45 | HAOUARI, Wafa, Orange | wafa.haouari@orange.com | Rel-17 | 89 |  |  |  |
| 1489 | 688.1 | CT1 aspects of SMS_SBI | 388d | 2020-09-16 A | 2022-03-11 A | 100% | finish no earlier than 2022-03-12 | C1 | 3104h | 3104h | SMS_SBI | 45 | HAOUARI, Wafa, Orange | wafa.haouari@orange.com | Rel-17 | 89 | 23.040 |  |  |
| 1490 | 688.2 | CT4 aspects of SMS_SBI | 388d | 2020-09-16 A | 2022-03-11 A | 100% | finish no earlier than 2022-03-12 | C4 | 3104h | 3104h | SMS_SBI | 45 | HAOUARI, Wafa, Orange | wafa.haouari@orange.com | Rel-17 | 89 | 29.503; 29.540; 29.571; 23.540; 29.577; 29.579; 29.578 |  |  |
| 1491 | 689 | **Enhanced Relays for Energy eFficiency and Extensive Coverage** | 331d? | 2018-09-06 A | 2019-12-12 A | 100% |  |  | 2704h | 2704h | REFEC | 43 | Norp, Toon, KPN | toon.norp@tno.nl | Rel-17 | 84 | 22.261 |  |  |
| 1492 | 689.1 | Study on REFEC | 202d? | 2018-09-06 A | 2019-06-14 A | 100% | finish no earlier than 2019-06-14 | S1 | 1616h | 1616h | FS_REFEC | 41 | Jose Luis Almodovar Chico, KPN | jose.almodovarchico@tno.nl | Rel-17 | 81 | 22.866 |  |  |
| 1493 | 689.2 | Stage 1 of REFEC | 136d | 2019-06-06 A | 2019-12-12 A | 100% | finish no earlier than 2019-12-12 | S1 | 1088h | 1088h | REFEC | 43 | Norp, Toon, KPN | toon.norp@tno.nl | Rel-17 | 84 | 22.261 |  |  |
| 1494 | 690 | **Network Controlled Interactive Service** | 397d? | 2018-06-06 A | 2019-12-12 A | 100% |  |  | 2704h | 2704h | NCIS | 43 | Ning YANG, oppo | yangning@oppo.com | Rel-17 | 84 | 22.261 |  |  |
| 1495 | 690.1 | Study on NCIS | 202d? | 2018-06-06 A | 2019-03-14 A | 100% | finish no earlier than 2019-03-14 | S1 | 1616h | 1616h | FS_NCIS | 41 | YANG Ning, Oppo | yangning@oppo.com | Rel-17 | 80 | 22.842 |  |  |
| 1496 | 690.2 | Stage 1 of NCIS | 136d | 2019-06-06 A | 2019-12-12 A | 100% | finish no earlier than 2019-12-12 | S1 | 1088h | 1088h | NCIS | 43 | Ning YANG, oppo | yangning@oppo.com | Rel-17 | 84 | 22.261 |  |  |
| 1497 | 691 | 5G System Enhancement for Advanced Interactive Services | 527d | 2019-06-06 A | 2021-06-11 A | 100% | finish no earlier than 2021-06-12 | S2 | 4216h | 4216h | 5G_AIS | 43 | Lei Yixue, Tencent | yixuelei@tencent.com | Rel-17 | 84 | 23.501; 23.502; 23.503 |  |  |
| 1498 | 692 | Points for 8K VR 360 Video over 5G | 193d | 2020-09-16 A | 2021-06-11 A | 100% | finish no earlier than 2021-06-12 | S4 | 1544h | 1544h | 8K_VR_5G | 45 | Ozgur Oyman, Company: Intel | ozgur.oyman@intel.com | Rel-17 | 89 | 26.118; 26.511; 26.925 |  |  |
| 1499 | 693 | **Multi-Device and multi-identity Enhancements (MuDE)** | 335d | 2019-09-02 A | 2020-12-11 A | 100% |  |  | 1088h | 1088h | MuDE | 43 | Adrian.buckley@vivo.com |  | Rel-17 | 85 | 22.173 |  |  |
| 1500 | 693.1 | Stage 1 of MuDE | 14d | 2019-09-02 A | 2019-09-19 A | 100% | finish no earlier than 2019-09-19 | S1 | 112h | 112h | MuDE | 43 | Adrian.buckley@vivo.com |  | Rel-17 | 85 | 22.173 |  |  |
| 1501 | 693.2 | Stage 3 of MuDE | 122d | 2020-06-25 A | 2020-12-11 A | 100% | finish no earlier than 2020-12-12 | C1 | 976h | 976h | MuDe | 45 | Adrian Buckley | adrian.buckley@vivo.com | Rel-17 | 88 |  |  |  |
| 1502 | 694 | **Best Practice of Packet Forwarding Control Protocol (PFCP)** | 448d | 2020-06-25 A | 2022-03-11 A | 100% |  | ct | 10728h | 10728h | BEPoP | 45 | Song Yue, China Mobile | songyue@chinamobile.com | Rel-17 | 88 | 29.820 |  |  |
| 1503 | 694.1 | CT3 aspects of BEPoP | 447d | 2020-06-25 A | 2022-03-11 A | 100% | finish no earlier than 2022-03-12 | C3 | 3576h | 3576h | BEPoP | 45 | Song Yue, China Mobile | songyue@chinamobile.com | Rel-17 | 88 | 29.820 |  |  |
| 1504 | 694.2 | CT4 aspects of BEPoP | 447d | 2020-06-25 A | 2022-03-11 A | 100% | finish no earlier than 2022-03-12 | C4 | 3576h | 3576h | BEPoP | 45 | Song Yue, China Mobile | songyue@chinamobile.com | Rel-17 | 88 | 29.820 |  |  |
| 1505 | 695 | Extension for headset interface tests of UE | 317d | 2020-06-25 A | 2021-09-10 A | 100% | start no earlier than 2020-06-25 | S4 | 2536h | 2536h | HInT | 45 | Jan Reimes, HEAD acoustics GmbH, | jan.reimes@head-acoustics.com | Rel-17 | 88 |  |  |  |
| 1506 | 696 | MC services support on IOPS mode of operation | 332d | 2019-06-06 A | 2020-09-11 A | 100% | finish no earlier than 2020-09-12 | S6 | 2656h | 2656h | MCIOPS | 43 | Camilo.solano@ericsson.com | 23.280; 23.379; 23.281; 23.282 | Rel-17 | 84 | 23.180 | Camilo Solano, Ericsson |  |
| 1507 | 697 | Stopped - Supporting Flexible Local Area Data Network | 332d | 2019-06-06 A | 2020-09-11 A | 100% | finish no earlier than 2020-09-11 | S2 | 2656h | 2656h | FLADN | 43 | LG Electronics, Hyunsook Kim | hyuns.kim@lge.com | Rel-17 | 84 | 23.501; 23.502 |  | 95 |
| 1508 | 698 | Support of Immersive Teleconferencing and Telepresence for Remote Terminals | 846.88d | 2018-12-13 A | 2022-03-11 A | 100% | finish no earlier than 2022-03-12 | S4 | 6775h | 6775h | ITT4RT | 42 | Ozgur Oyman, Intel | Ozgur.Oyman@Intel.com | Rel-17 | 82 | 26.114; 26.223; 26.962; 26.862 |  |  |
| 1509 | 699 | Handsets Featuring Non-Traditional Earpieces | 591d | 2019-12-06 A | 2022-03-11 A | 100% | finish no earlier than 2022-03-12 | S4 | 4728h | 4728h | HaNTE | 44 | Schevciw, Andre, Qualcomm Incorporated | aschevci@qti.qualcomm.com | Rel-17 | 86 | 26.131; 26.132; 26.801 |  |  |
| 1510 | 700 | **5GMS AF Event Exposure** | 262d | 2021-06-11 A | 2022-06-10 A | 100% |  | S4 | 4240h | 4240h | EVEX | 47 | Lo, Charles, Qualcomm Inc., | clo@qti.qualcomm.com | Rel-17 | 92 | 26.512;26.501 ; 26.531; 26.532 |  |  |
| 1511 | 700.1 | Stage 2 of EVEX | 261d | 2021-06-11 A | 2022-06-10 A | 100% | finish no earlier than 2022-06-12 | S4 | 2088h | 2088h | EVEX | 47 | Lo, Charles, Qualcomm Inc., | clo@qti.qualcomm.com | Rel-17 | 92 | 26.512;26.501 ; 26.531; 26.532 |  |  |
| 1512 | 700.2 | Stage 3 (CT3) of EVEX | 8d | 2022-06-01 A | 2022-06-10 A | 100% | finish no earlier than 2022-06-10 | C3 | 64h | 64h | EVEX | 49 | Waqar Zia, Qualcomm Incorporated | wzia@qti.qualcomm.com | Rel-17 | 96 | 29.522; 29.517; 29.591 |  |  |
| 1513 | 701 | Edge Extensions to the 5G Media Streaming Architecture | 64d | 2021-06-11 A | 2021-09-08 A | 100% | start no earlier than 2021-06-11 | S4 | 512h | 512h | 5GMS_EDGE | 47 | Bouazizi, Imed, Qualcomm Inc. | bouazizi@qti.qualcomm.com | Rel-17 | 92 | 26.501 |  |  |
| 1514 | 702 | 5G Multicast-Broadcast User Service Architecture and related 5GMS Extensions | 196d | 2021-06-11 A | 2022-03-11 A | 100% | finish no earlier than 2022-03-12 | S4 | 1568h | 1568h | 5MBUSA | 47 | TAN, PENG, TELUS | peng.tan@telus.com | Rel-17 | 92 | 26.501 ; 26.502 |  |  |
| 1515 | 703 | 8K Television over 5G | 196d | 2021-06-11 A | 2022-03-11 A | 100% | start no earlier than 2021-06-11 | S4 | 1568h | 1568h | 8K_TV_5G | 47 | Thomas Stockhammer | tsto@qti.qualcomm.com | Rel-17 | 92 | 26.955;26.925;26.511;26.116 |  |  |
| 1516 | 704 | Verification-modified Calling Name Display | 11d? | 2019-03-07 A | 2019-03-21 A | 100% | finish no earlier than 2019-03-21 | S1 | 88h | 88h | VMOD_DISPLAY | 42 | Hala Mowafy, Ericsson | Hala.Mowafy@ericsson.com | Rel-17 | 83 | 22.173 |  |  |
| 1517 | 705 | Enhanced Calling Name Service Analytics Interworking | 14d | 2019-09-02 A | 2019-09-19 A | 100% | finish no earlier than 2019-09-19 | S1 | 112h | 112h | eCNAM_An | 43 | Hala.Mowafy@ericsson.com |  | Rel-17 | 85 | 22.173 |  |  |

Notes:
- 1488: 25/9/20: WID:CP-202028->CP-202242; 10/9/21: WID:CP-202242->CP-212023
- 1489: 12/3/22: FCD:12/03/2021->3/22; 12/3/22: 0%->100
- 1490: 13/9/20: FCD:12/03/2021->09/21; 5/12/20: 0%->15; 21/3/21: 15%->25; 11/6/21: 25%->35; 13/9/21: FCD:Wed 08/09/->03/22; 13/9/21: 35%->40; 1/10/21: 23.540 added;; 13/12/21: 40%->45; 12/3/22: 45%->65; 22/3/22: 29.577 added;; 22/3/22: 29.579 added;; 22/3/22: ; 3/8/22: 99%->90
- 1492: 4/12/18: 0%->20¦14/3/19: 20%->40; 31/5/19: 40%->60; 13/9/19: 60%->95; 6/12/19: 95%->100
- 1493: 13/9/19: 0%->90; 6/12/19: 90%->100
- 1495: 6/8/18: 22.842 added;¦10/9/18: 0%->25¦4/12/18: 25%->60¦14/3/19: 60%->85; 31/5/19: 85%->100
- 1496: 13/9/19: 0%->85; 6/12/19: 80%->100; 12/12/19: WID:SP-190303->SP-191039
- 1497: 5/12/20: 0%->10; 5/12/20: FCD:10/09/2020->06/20; 19/3/21: 10%->40; 11/6/21: 40%->100
- 1498: ; 5/12/20: 0%->25; 21/3/21: 25%->85; 21/3/21: FCD:12/03/2021->06/21; 11/6/21: 85%->100
- 1499: ; 13/9/19: 0%->100
- 1500: ; 13/9/19: 0%->100
- 1501: 24.174 ; 13/9/20: 0%->15; 21/3/21: 15%->40; 11/6/21: 40%->100
- 1502: 29.244; 29.510 ; 2/7/20: 0%->5; 13/9/20: 5%->10; 25/9/20: 29.820 added;; 5/12/20: 10%->20; 21/3/21: 20%->30; 11/6/21: WID:CP-201076->CP-210074; 10/9/21: WID:CP-210074->CP-212024
- 1503: 29.244; 29.510 ; 2/7/20: 0%->5; 13/9/20: 5%->10; 25/9/20: 29.820 added;; 5/12/20: 10%->20; 21/3/21: 20%->30; 11/6/21: 0%->60; 10/9/21: FCD:Wed 15/09/->03/22; 13/9/21: 60%->85; 12/3/22: 85%->100
- 1504: 29.244; 29.510 ; 2/7/20: 0%->5; 13/9/20: 5%->10; 25/9/20: 29.820 added;; 5/12/20: 10%->20; 21/3/21: 20%->30; 11/6/21: 30%->45; 10/9/21: FCD:Wed 15/09/->03/22; 13/9/21: 45%->55; 13/12/21: 55%->80; 12/3/22: 80%->100
- 1505: 26.131; 26.132 ; 12/9/20: 0%->10; 5/12/20: 10%->25; 21/3/21: 25%->50; 11/6/21: 50%->70; 13/9/21: 70%->75; 13/12/21: 75%->100
- 1506: 13/9/19: 0%->10; 20/9/19: WID:SP-190480->SP-190944; 8/10/19: 23.180 added;; 6/12/19: 10%->40; 26/3/20: FCD:12/03/2020->09/20; 26/3/20: 40%->50; 28/6/20: 50%->75; 13/9/20: 75%->95; 5/12/20: 95%->100
- 1507: 21/1/22: stopped at 0%; 21/1/22: 0%->100
- 1508: 7/3/19: 0%->5%; 31/5/19: 0%->10; 13/9/19: 10%->20; 6/12/19: 20%->25; 25/3/20: 25%->35; 10/6/20: 35%->45; 26/6/20: 45%->45; 12/9/20: 45%->50; 5/12/20: 50%->55; 5/12/20: FCD:18/12/2020->06/20; 21/3/21: 55%->60; 11/6/21: 60%->75; 11/6/21: FCD:Fri 11/06/->
- 1509: 25/3/20: 0%->5; 20/4/20: FCD:12/03/2020->09/20. Study in Rel-16; 10/6/20: 5%->25; 26/6/20: 25%->25; 12/9/20: 25%->35; 12/9/20: FCD:15/09/2020->12/20; 5/12/20: 35%->35; 5/12/20: FCD:15/12/2020->03/20; 21/3/21: 35%->50; 21/3/21: FCD:12/03/2021->09/21; 11
- 1510: ; 13/9/21: 0%->10; 1/10/21: 26.531 & 26.532 added;; 13/12/21: 10%->40; 12/3/22: 40%->60; 12/3/22: FCD:11/03/2022->6/22
- 1511: ; 13/9/21: 0%->10; 1/10/21: 26.531 & 26.532 added;; 13/12/21: 10%->40; 12/3/22: 40%->60; 12/3/22: FCD:11/03/2022->6/22; 4/6/22: 60%->100
- 1513: ; 13/9/21: 0%->30; 13/12/21: 30%->100
- 1514: ; 13/9/21: 0%->5; 1/10/21: 26.502 added;; 13/12/21: 5%->60; 12/3/22: FCD:10/06/2022->3/22; 12/3/22: 60%->100
- 1515: ; 13/9/21: 0%->40; 13/12/21: 40%->60; 12/3/22: 60%->100
- 1516: 14/3/19: 0%->100
- 1517: ; 13/9/19: 0%->100

| ID | WBS | Task | Duration | Start | Finish | Complete | Constraint | Resources | Work | Actual work | Acronym | PCG approved | WI rapporteur name | WI rapporteur e-mail | Release | TSG approved | Status Report |
| --- | --- | --- | --- | --- | --- | --- | --- | --- | --- | --- | --- | --- | --- | --- | --- | --- | --- |
| 1518 | 706 | **Enhancement for the 5G Control Plane Steering of Roaming for UE in Connected mode** | 916d | 2019-09-02 A | 2023-03-03 A | 100% |  |  | 15504h | 15504h | eCPSOR_CON | 43 | Minokuchi, Atsushi, NTT DOCOMO | minokuchi at nttdocomo dot com | Rel-17 | 85 |  |
| 1519 | 706.1 | Stage 1 of eCPSOR_CON | 470d | 2019-09-02 A | 2021-06-18 A | 100% | finish no earlier than 2021-06-20 | S1 | 3760h | 3760h | eCPSOR_CON | 43 | Minokuchi, Atsushi, NTT DOCOMO | minokuchi at nttdocomo dot com | Rel-17 | 85 |  |
| 1520 | 706.2 | Stage 3 (CT1) of eCPSOR_CON | 447d | 2020-06-25 A | 2022-03-11 A | 100% | finish no earlier than 2022-03-12 | C1 | 3576h | 3576h | eCPSOR_CON | 45 | Al-Bakri Ban, NTT DOCOMO | ban.albakri@meadowcom.com | Rel-17 | 88 |  |
| 1521 | 706.3 | Stage 3 (CT4) of eCPSOR_CON | 447d | 2020-06-25 A | 2022-03-11 A | 100% | finish no earlier than 2022-03-11 | C4 | 3576h | 3576h | eCPSOR_CON | 46 | Al-Bakri Ban, NTT DOCOMO | ban.albakri@meadowcom.com | Rel-17 | 90 |  |
| 1522 | 706.4 | Stage 3 (CT6) of eCPSOR_CON | 447d | 2020-06-25 A | 2022-03-11 A | 100% | finish no earlier than 2022-03-12 | C6 | 3576h | 3576h | eCPSOR_CON | 47 | Al-Bakri Ban, NTT DOCOMO | ban.albakri@meadowcom.com | Rel-17 | 92 |  |
| 1523 | 706.5 | UE Conformance - Enhancement for the 5G Control Plane Steering of Roaming for UE in Connected mode | 127d | 2022-09-08 A | 2023-03-03 A | 100% | finish no earlier than 2023-03-03 | R5 | 1016h | 1016h | eCPSOR_CON-UEConTest | 49 | Masahiro Takano, NTT DOCOMO, INC | masahiro[dot]takano[dot]ru[at]nttdocomo[dot]com | Rel-17 | 97 | RP-230359 |
| 1524 | 707 | **Integration of Generic Bootstrapping Architecture (GBA) into 5GC** | 984d | 2018-06-06 A | 2022-03-11 A | 100% |  |  | 14571.4h | 14571.4h | GBA_5G | 43 | Vlasios Tsiatsis, Ericsson | vlasios.tsiatsis@ericsson.com | Rel-17 | 85 |  |
| 1525 | 707.1 | Security aspects of Integration of GBA into 5GC | 582d | 2019-09-19 A | 2021-12-10 A | 100% | finish no earlier than 2021-12-12 | S3 | 4656h | 4656h | GBA_5G | 43 | Vlasios Tsiatsis, Ericsson | vlasios.tsiatsis@ericsson.com | Rel-17 | 85 |  |
| 1526 | 707.2 | CT aspects of Integration of GBA into SBA | 257d | 2021-03-18 A | 2022-03-11 A | 100% | finish no earlier than 2022-03-12 | C4 | 2056h | 2056h | GBA_5G | 46 | de Gregorio, Jesús (Ericsson) | jesus.de.gregorio@ericsson.com | Rel-17 | 91 |  |
| 1527 | 707.3 | Integration of Generic Bootstrapping Architecture (GBA) into 5GC | 982.42d | 2018-06-06 A | 2022-03-11 A | 100% | finish no earlier than 2022-03-12 | S3 | 7859.36h | 7859.36h | GBA_5G | 43 | Vlasios Tsiatsis, Ericsson | vlasios.tsiatsis@ericsson.com | Rel-17 | 85 |  |
| 1528 | 708 | **Support for Minimization of service Interruption** | 788d | 2019-03-07 A | 2022-03-11 A | 100% |  |  | 6615h | 6615h | MINT | 43 | SungDuck Chun; LG Electronics | sungduck.chun@lge.com | Rel-17 | 85 |  |
| 1529 | 708.1 | Study on MINT | 130.88d | 2019-03-07 A | 2019-09-05 A | 100% |  | S1 | 1047h | 1047h | FS_MINT | 42 | SungDuck Chun; LG Electronics | sungduck.chun@lge.com | Rel-17 | 83 |  |
| 1530 | 708.2 | Stage 1 of MINT | 65d | 2019-09-13 A | 2019-12-12 A | 100% | finish no earlier than 2019-12-12 | S1 | 520h | 520h | MINT | 43 | SungDuck Chun; LG Electronics | sungduck.chun@lge.com | Rel-17 | 85 |  |
| 1531 | 708.3 | Stage 2 of MINT | 87d | 2021-08-12 A | 2021-12-10 A | 100% | finish no earlier than 2021-12-12 | S2 | 696h | 696h | MINT | 47 | Hyunsook Kim, LG Electronics | hyuns.kim@lge.com | Rel-17 | 92 |  |
| 1532 | 708.4 | Study on the CT aspects of Support for Minimization of service Interruption | 70d | 2020-12-07 A | 2021-03-12 A | 100% | finish no earlier than 2021-03-12 | C1 | 560h | 560h | FS_MINT-CT | 46 | Sang Min Park, LG Electronics | sangmin2.park@lge.com | Rel-17 | 90 |  |
| 1533 | 708.5 | **Stage 3 of MINT** | 119d | 2021-09-29 A | 2022-03-11 A | 100% |  | ct | 3776h | 3776h | MINT | 47 | Hyunsook Kim, LG Electronics | hyuns.kim@lge.com | Rel-17 | 93 |  |
| 1534 | 708.5.1 | CT1 aspects of MINT | 118d | 2021-09-29 A | 2022-03-11 A | 100% | finish no earlier than 2022-03-12 | C1 | 944h | 944h | MINT | 47 | Hyunsook Kim, LG Electronics | hyuns.kim@lge.com | Rel-17 | 93 |  |
| 1535 | 708.5.2 | CT4 aspects of MINT | 118d | 2021-09-29 A | 2022-03-11 A | 100% | finish no earlier than 2022-03-12 | C4 | 944h | 944h | MINT | 47 | Hyunsook Kim, LG Electronics | hyuns.kim@lge.com | Rel-17 | 93 |  |
| 1536 | 708.5.3 | CT6 aspects of MINT | 118d | 2021-09-29 A | 2022-03-11 A | 100% | finish no earlier than 2022-03-12 | C6 | 944h | 944h | MINT | 47 | Hyunsook Kim, LG Electronics | hyuns.kim@lge.com | Rel-17 | 93 |  |
| 1537 | 708.6 | Security Aspects of MINT | 2d | 2022-03-10 A | 2022-03-11 A | 100% | finish no earlier than 2022-03-12 | S3 | 16h | 16h | MINT | 48 | Dongjoo Kim, LG Electronics | dongjoo7.kim@lge.com | Rel-17 | 95 |  |
| 1538 | 709 | IMS emergency support for Stand-alone Non-Public Network (SNPN) | 6d | 2019-12-06 A | 2019-12-13 A | 100% | finish no earlier than 2019-12-13 | S1 | 48h | 48h | IESNPN | 44 | Wong, Curt; | curt.wong@charter.com | Rel-17 | 86 |  |
| 1539 | 710 | Management of non-public networks (NPN) | 513d | 2020-03-25 A | 2022-03-11 A | 100% | finish no earlier than 2022-03-12 | S5 | 4104h | 4104h | OAM_NPN | 44 | ZHANG, Kai, Huawei | kai.zhangkai@huawei.com | Rel-17 | 87 |  |
| 1540 | 711 | Assurance Specification for IMS | 396d | 2019-12-06 A | 2021-06-11 A | 100% | finish no earlier than 2021-06-12 | S3 | 3168h | 3168h | SCAS_IMS | 44 | Bo Zhang, Huawei Technologies | zhangbo6@huawei.com | Rel-17 | 86 |  |
| 1541 | 712 | **Security Assurance Specification for 5G (eSCAS_5G)** | 579d | 2020-03-25 A | 2022-06-10 A | 100% |  | S3 | 23168h | 23168h | eSCAS_5G | 44 | Rong Wu, Huawei Technologies Co. | Raina.wu@huawei.com | Rel-17 | 87 |  |
| 1542 | 712.1 | eSCAS_5G for Network Slice-Specific Authentication and Authorization Function (NSSAAF) | 323d | 2020-09-16 A | 2021-12-10 A | 100% | finish no earlier than 2021-12-12 | S3 | 2584h | 2584h | SCAS_5G_NSSAAF | 45 | Rong Wu, Huawei Technologies Co., Ltd. | Raina.wu@huawei.com | Rel-17 | 89 |  |
| 1543 | 712.2 | eSCAS_5G for Non-3GPP InterWorking Function | 448d | 2020-03-25 A | 2021-12-10 A | 100% | finish no earlier than 2021-12-12 | S3 | 3584h | 3584h | SCAS_5G_N3IWF | 44 | Feng Gao, China Unicom | gaofeng149@chinaunicom.cn | Rel-17 | 87 |  |
| 1544 | 712.3 | eSCAS_5G for 5G NWDAF | 578d | 2020-03-25 A | 2022-06-10 A | 100% | finish no earlier than 2022-06-12 | S3 | 4624h | 4624h | SCAS_5G_NWDAF | 44 | QI Minpeng, China Mobile | qiminpeng@chinamobile.com | Rel-17 | 87 |  |
| 1545 | 712.4 | eSCAS_5G for Service Communication Proxy | 578d | 2020-03-25 A | 2022-06-09 A | 100% | finish no earlier than 2022-06-12 | S3 | 4624h | 4624h | SCAS_5G_SECOP | 44 | Wei Lu, Nokia | wei.lu@nokia-sbell.com | Rel-17 | 87 |  |
| 1546 | 712.5 | eSCAS_5Gfor Inter PLMN UP Security | 391d | 2020-06-12 A | 2021-12-10 A | 100% | finish no earlier than 2021-12-12 | S3 | 3128h | 3128h | SCAS_5G_IPUPS | 45 | Jin PENG, ZTE Corporation | peng.jin1@zte.com.cn | Rel-17 | 88 |  |

Notes:
- 1518: ; 13/9/19: 0%->100; 13/6/21: WID:SP-190941->CP-210148 / Impacted TSs and TRs: 22.261
- 1519: ; 13/9/19: 0%->100; 5/12/20: 100%->10; 5/12/20: FCD:19/09/2019->06/20; 11/3/22: 10%->100 / Impacted TSs and TRs: 22.261
- 1520: 23.122; 24.501; 29.503; 29.505; 29.550; 29.509; 29.571; 31.102; 31.111 ; 13/9/20: 0%->5; 13/9/20: WID:CP-201166->CP-202186; 21/3/21: 5%->35; 11/6/21: 35%->50; 13/9/21: 50%->70; 13/9/21: FCD:Fri 18/06/->03/22; 13/12/21: 70%->92; 12/3/22: 92%->100
- 1521: 23.122; 24.501; 29.503; 29.505; 29.550; 29.509; 29.571; 31.102; 31.111 ; 13/9/20: 0%->5; 13/9/20: WID:CP-201166->CP-202186; 5/12/20: 0%->5; 21/3/21: 5%->5; 11/6/21: 5%->10; 13/12/21: 10%->70; 13/12/21: FCD:Fri 18/06/->03/22; 12/3/22: 70%->100
- 1522: 23.122; 24.501; 29.503; 29.505; 29.550; 29.509; 29.571; 31.102; 31.111 ; 13/9/20: 0%->5; 13/9/20: WID:CP-201166->CP-202186; 5/12/20: 0%->5; 21/3/21: 5%->5; 11/6/21: 5%->10; 13/9/21: 0%->70; 13/9/21: FCD:Fri 18/06/->03/22; 12/3/22: 70%->100; 4/6/22: 100
- 1523: 9/12/22: FCD:08/09/2023->01/09/2023; Compl:0%->80%; Stat Rep: ->RP-223159; Rapporteur: NTT DOCOMO->Masahiro Takano, NTT DOCOMO, INC; Rap eMail: ->masahiro[dot]takano[dot]ru[at]nttdocomo[dot]com; 17/3/23: FCD:09/09/2023->03/03/2023; Compl:80%->100%; ...
- 1524: 26/6/20: FCD:12/06/2020->09/20; 26/6/20: 0%->5; 12/9/20: 5%->50; 12/9/20: FCD:15/09/2020->12/20; 5/12/20: 50%->55; 5/12/20: FCD:15/12/2020->03/20 / Impacted TSs and TRs: 33.220; 33.222; 33.223; 33.501
- 1525: 26/6/20: FCD:12/06/2020->09/20; 26/6/20: 0%->5; 12/9/20: 5%->50; 12/9/20: FCD:15/09/2020->12/20; 5/12/20: 50%->55; 5/12/20: FCD:15/12/2020->03/20; 19/3/21: FCD:12/03/2021->09/21; 11/6/21: FCD:Wed 08/09/->12/21; 13/9/21: 55%->80; 13/12/21: 80%->100 / Impacted TSs and TRs: 33.220; 33.222; 33.223; 33.501
- 1526: ; 21/3/21: 0%->5; 11/6/21: 5%->15; 13/9/21: 15%->60; 13/12/21: 60%->80; 12/3/22: 80%->100 / Impacted TSs and TRs: 29.503; 29.505; 29.510; 29.562; 29.571
- 1527: 26/6/20: FCD:12/06/2020->09/20; 26/6/20: 0%->5; 12/9/20: 5%->50; 12/9/20: FCD:15/09/2020->12/20; 5/12/20: 50%->55; 5/12/20: FCD:15/12/2020->03/20; 24/3/22: 0%->100 / Impacted TSs and TRs: 33.220; 33.222; 33.223; 33.501
- 1528: Impacted TSs and TRs: 22.011; 22.261
- 1529: 31/5/19: 0%->65; 13/9/19: 65%->100 / Impacted TSs and TRs: New
- 1530: 13/9/19: 0%->80; 6/12/19: 80%->100 / Impacted TSs and TRs: 22.011; 22.261
- 1531: 13/9/21: 0%->50; 10/12/21: 50%->90; 12/3/22: 90%->98; 4/6/22: 98%->100 / Impacted TSs and TRs: 23.501; 23.502
- 1532: 21/3/21: 0%->60; 11/6/21: 60%->95; 13/9/21: 95%->100
- 1533: Impacted TSs and TRs: 23.122; 24.501; 31.102; 31.111
- 1534: ; 13/12/21: 0%->50; 12/3/22: 50%->85; 4/6/22: 85%->100 / Impacted TSs and TRs: 23.122; 24.501; 31.102; 31.111
- 1535: ; 12/3/22: 0%->80; 20/6/22: Compl:80%->100% / Impacted TSs and TRs: 23.122; 24.501; 31.102; 31.111
- 1536: ; 12/3/22: 0%->100; 4/6/22: 100%->100 / Impacted TSs and TRs: 23.122; 24.501; 31.102; 31.111
- 1537: ; 22/3/22: 0%->100 / Impacted TSs and TRs: 33.501
- 1538: 6/12/19: 0%->100 / Impacted TSs and TRs: 22.101; 22.261; 22.228
- 1539: ; 13/9/20: 0%->5; 5/12/20: 5%->15; 21/3/21: 15%->35; 11/6/21: 35%->50; 11/6/21: FCD:Wed 16/06/->12/21; 13/9/21: 50%->70; 13/12/21: 70%->85; 13/12/21: FCD:Fri 10/12/->03/22; 12/3/22: 85%->100 / Impacted TSs and TRs: 28.541; 28.531; 28.533; 28.552; 28.554
- 1540: ; 26/6/20: 0%->15; 12/9/20: 15%->40; 5/12/20: 40%->60; 5/12/20: FCD:11/12/2020->03/20; 19/3/21: 60%->80; 19/3/21: FCD:12/03/2021->06/21; 11/6/21: 80%->90; 13/12/21: 90%->100 / Impacted TSs and TRs: 33.926
- 1541: 26/6/20: 0%->5 / Impacted TSs and TRs: 33.926; 33.117; 33.511; 33.512; 33.513; 33.514; 33.515; 33.516; 33.517; 33.518; 33.519
- 1542: 5/12/20: 0%->5; 19/3/21: 5%->40; 9/4/21: 40%->60; 11/6/21: 60%->45; 11/6/21: FCD:Fri 11/06/->12/21; 13/9/21: 45%->100 / Impacted TSs and TRs: 33.926; 33.326
- 1543: 26/6/20: 0%->10; 19/3/21: 10%->20; 19/3/21: FCD:17/03/2021->06/21; 9/4/21: 20%->60; 11/6/21: 60%->20; 11/6/21: FCD:Fri 11/06/->12/21; 13/12/21: 20%->100 / Impacted TSs and TRs: 33.926; 33.520
- 1544: 26/6/20: 0%->10; 5/12/20: 10%->60; 19/3/21: 60%->70; 19/3/21: FCD:17/03/2021->06/21; 11/6/21: 70%->85; 11/6/21: FCD:Fri 11/06/->12/21; 11/6/21: 85%->; 13/9/21: 85%->90; 12/3/22: FCD:10/12/2021->06/22; 4/6/22: 90%->100 / Impacted TSs and TRs: 33.521; 33.926
- 1545: 26/6/20: 0%->10; 12/9/20: 10%->20; 19/3/21: FCD:17/03/2021->06/21; 9/4/21: 20%->60; 11/6/21: 60%->70; 11/6/21: FCD:Fri 11/06/->12/21; 13/12/21: 70%->95; 12/3/22: 95%->95; 12/3/22: FCD:10/12/2021->06/22; 31/3/23: 95%->100 / Impacted TSs and TRs: 33.522; 33.926
- 1546: 33.926; 33.513 ; 12/9/20: 0%->20; 19/3/21: 20%->70; 11/6/21: 70%->90; 11/6/21: FCD:Fri 11/06/->12/21; 13/9/21: 90%->100

| ID | WBS | Task | Duration | Start | Finish | Complete | Constraint | Resources | Work | Actual work | Acronym | PCG approved | WI rapporteur name | WI rapporteur e-mail | Release | TSG approved |
| --- | --- | --- | --- | --- | --- | --- | --- | --- | --- | --- | --- | --- | --- | --- | --- | --- |
| 1547 | 713 | **Enhanced Mission Critical Push-to-talk architecture phase 3** | 381d | 2020-03-25 A | 2021-09-08 A | 100% |  |  | 4624h | 4624h | enh3MCPTT | 44 | Dom Lazara; Motorola Solutions | Dom.Lazara@motorolasolutions.com | Rel-17 | 87 |
| 1548 | 713.1 | Stage 2 aspects of enh3MCPTT | 320d | 2020-03-25 A | 2021-06-15 A | 100% | finish no earlier than 2021-06-15 | S6 | 2560h | 2560h | enh3MCPTT | 44 | Dom Lazara; Motorola Solutions | Dom.Lazara@motorolasolutions.com | Rel-17 | 87 |
| 1549 | 713.2 | Stage 3 aspects of enh3MCPTT | 258d | 2020-09-14 A | 2021-09-08 A | 100% | finish no earlier than 2021-09-08 | C1 | 2064h | 2064h | enh3MCPTT-CT | 44 |  |  | Rel-17 | 87 |
| 1550 | 714 | IMS Charging in 5G System Architecture | 657d | 2019-06-06 A | 2021-12-10 A | 100% | finish no earlier than 2021-12-12 | S5 | 5256h | 5256h | 5GSIMSCH | 43 | Jahangir, Zeeshan, T-Mobile USA | Zeeshan.jahangir@t-mobile.com | Rel-17 | 84 |
| 1551 | 715 | Study on User Plane Integrity Protection | 587d | 2018-12-13 A | 2021-03-12 A | 100% | finish no earlier than 2021-03-12 | S3 | 4696h | 4696h | FS_UP_IP_Sec | 42 | Evans, Tim, Vodafone | tim.evans1@vodafone.com | Rel-17 | 82 |
| 1552 | 716 | Enhancements to User Plane Integrity Protection Support in 5GS | 128d | 2020-09-16 A | 2021-03-12 A | 100% | finish no earlier than 2021-03-12 | S3 | 1024h | 1024h | eUPIP_SEC | 45 | Anand Palanigounder, Qualcomm Incorporated | apg@qti.qualcomm.com | Rel-17 | 89 |
| 1553 | 717 | **Non-Seamless WLAN offload in 5GS** | 210d | 2021-05-25 A | 2022-03-11 A | 100% |  | S3 | 2864h | 2864h | NSWO_5G | 48 | Ranganathan Mavureddi Dhanasekaran, Nokia | ranganathan.mavureddi_dhanasekaran@nokia-bell-labs.com | Rel-17 | 95 |
| 1554 | 717.1 | Study on non-seamless WLAN Offload in 5GS using 3GPP credentials | 77d | 2021-05-25 A | 2021-09-08 A | 100% | finish no earlier than 2021-09-08 | S3 | 616h | 616h | FS_NSWO_5G | 46 | Nair, Suresh, Nokia | suresh.p.nair@nokia.com | Rel-17 | 91 |
| 1555 | 717.2 | Security aspects of NSWO | 66d | 2021-12-10 A | 2022-03-11 A | 100% | finish no earlier than 2022-03-12 | S3 | 528h | 528h | NSWO_5G | 48 | Ranganathan Mavureddi Dhanasekaran, Nokia | ranganathan.mavureddi_dhanasekaran@nokia-bell-labs.com | Rel-17 | 94 |
| 1556 | 717.3 | CT1 aspects of NSWO | 2d | 2022-03-10 A | 2022-03-11 A | 100% | finish no earlier than 2022-03-12 | C1 | 16h | 16h | NSWO_5G | 48 | Wiehe, Ulrich, Nokia | ulrich.wiehe@nokia.com | Rel-17 | 95 |
| 1557 | 717.4 | CT4 aspects of NSWO | 2d | 2022-03-10 A | 2022-03-11 A | 100% | finish no earlier than 2022-03-12 | C4 | 16h | 16h | NSWO_5G | 48 | Wiehe, Ulrich, Nokia | ulrich.wiehe@nokia.com | Rel-17 | 95 |
| 1558 | 717.5 | CT6 aspects of NSWO | 2d | 2022-03-10 A | 2022-03-11 A | 100% | finish no earlier than 2022-03-12 | C6 | 16h | 16h | NSWO_5G | 48 | Wiehe, Ulrich, Nokia | ulrich.wiehe@nokia.com | Rel-17 | 95 |
| 1559 | 718 | **Lawful Interception Rel-17** | 655d | 2019-12-10 A | 2022-06-10 A | 100% |  | S3 | 20944h | 20944h | LI17 | 44 | Alex Leadbeater, BT | alex.leadbeater@bt.com | Rel-17 | 86 |
| 1560 | 718.1 | Lawful Interception Rel-17 general aspects | 654d | 2019-12-10 A | 2022-06-10 A | 100% | finish no earlier than 2022-06-12 | S3 | 5232h | 5232h | LI17 | 44 | Alex Leadbeater, BT | alex.leadbeater@bt.com | Rel-17 | 86 |
| 1561 | 718.2 | (IETF) PASSporT Extension for Rich Call Data (draft-ietf-stir-passport-rcd) | 655d | 2019-12-10 A | 2022-06-10 A | 100% | finish no earlier than 2022-06-10 | S3-IETF | 5240h | 5240h | LI17 | 50 | Lionel Morand, Orange | lionel.morand@orange.com | Rel-17 | 99 |
| 1562 | 718.3 | (IETF) Messaging Use Cases and Extensions for STIR (draft-ietf-stir-messaging) | 655d | 2019-12-10 A | 2022-06-10 A | 100% | finish no earlier than 2022-06-10 | S3-IETF | 5240h | 5240h | LI17 | 50 | Lionel Morand, Orange | lionel.morand@orange.com | Rel-17 | 99 |
| 1563 | 719 | **(Small) Technical Enhancements and Improvements for Rel-17** | 524d | 2020-03-11 A | 2022-03-11 A | 100% |  |  | 39464h | 39464h | TEI17 | 43 |  |  | Rel-17 | 85 |
| 1564 | 719.1 | **IMS Optimization for HSS Group ID in an SBA environment (St. 2)** | 524d | 2020-03-11 A | 2022-03-11 A | 100% |  | S2 | 8832h | 8832h | TEI17_IMSGID | 44 | Foti, George, Ericsson | George.foti@ericsson.com | Rel-17 | 87 |
| 1565 | 719.1.1 | Stage 2 for TEI17_IMSGID | 58d | 2020-03-25 A | 2020-06-12 A | 100% | finish no earlier than 2020-06-12 | S2 | 464h | 464h | TEI17_IMSGID | 44 | Foti, George, Ericsson | George.foti@ericsson.com | Rel-17 | 87 |
| 1566 | 719.1.2 | Stage 3 for TEI17_IMSGID | 523d | 2020-03-11 A | 2022-03-11 A | 100% |  | C1 | 4184h | 4184h | TEI17_IMSGID | 48 | Axell, Jörgen, Ericsson | Jorgen.Axell@ericsson.com | Rel-17 | 94 |
| 1567 | 719.2 | **Same PCF Selection For AMF and SMF** | 381d | 2020-03-25 A | 2021-09-08 A | 100% |  |  | 2960h | 2960h | TEI17_SPSFAS | 45 | Heng, Nie, China Telecom | nieheng@chinatelecom.cn | Rel-17 | 88 |
| 1568 | 719.2.1 | Stage 2 for TEI17_SPSFAS | 58d | 2020-03-25 A | 2020-06-12 A | 100% | finish no earlier than 2020-06-12 | S2 | 464h | 464h | TEI17_SPSFAS | 45 | Heng, Nie, China Telecom | nieheng@chinatelecom.cn | Rel-17 | 88 |
| 1569 | 719.2.2 | **CT aspects on TEI17_SPSFAS** | 125d | 2021-03-18 A | 2021-09-08 A | 100% |  | ct | 2496h | 2496h | TEI17_SPSFAS | 46 | Yue Sun, China Telecom | suny20@chinatelecom.cn | Rel-17 | 91 |
| 1570 | 719.2.2.1 | CT3 aspects on TEI17_SPSFAS | 125d | 2021-03-18 A | 2021-09-08 A | 100% | finish no earlier than 2021-09-08 | C3 | 1000h | 1000h | TEI17_SPSFAS | 46 | Yue Sun, China Telecom | suny20@chinatelecom.cn | Rel-17 | 91 |
| 1571 | 719.2.2.2 | CT4 aspects on TEI17_SPSFAS | 62d | 2021-03-18 A | 2021-06-11 A | 100% | finish no earlier than 2021-06-12 | C4 | 496h | 496h | TEI17_SPSFAS | 46 | Yue Sun, China Telecom | suny20@chinatelecom.cn | Rel-17 | 91 |

Notes:
- 1547: ; 28/6/20: 0%->20 / Impacted TSs and TRs: 23.379; 23.280; 23.281; 23.282; 23.283
- 1548: ; 28/6/20: 0%->20; 13/9/20: 20%->35; 5/12/20: 35%->45; 10/2/21: FCD:17/09/2020->06/21; 21/3/21: 45%->60; 11/6/21: 60%->100 / Impacted TSs and TRs: 23.379; 23.280; 23.281; 23.282; 23.283
- 1549: ; 28/6/20: 0%->20; 13/9/20: 20%->35; 5/12/20: 35%->45; 5/12/20: 0%->45; 11/6/21: 45%->48; 13/12/21: 48%->100 / Impacted TSs and TRs: 23.379; 23.280; 23.281; 23.282; 23.283
- 1550: 13/9/19: 0%->10; 6/12/19: 10%->30; 25/03/20: Rel-16->Rel-17; 5/12/20: 30%->40; 5/12/20: FCD:12/03/2020->03/20; 21/3/21: 40%->60; 13/9/21: 60%->80; 13/9/21: FCD:Fri 12/03/->12/21; 12/3/22: 80%->100 / Impacted TSs and TRs: 32.240; 32.260; 32.275; 32.281; 32.290; 32.291; 32.298; 32.297
- 1551: 20/3/19: 0%->15¦20/3/19: 0%->15; 31/5/19: 15%->25; 13/9/19: 25%->50; 13/9/19: FCD:19/09/2019->12/20; 6/12/19: 50%->65; 6/12/19: FCD:12/12/2019->03/20; 25/03/20: Rel-16->Rel-17; 26/6/20: FCD:12/03/2020->12/20; 26/6/20: 65%->75; 12/9/20: 75%->85; 5/12/20
- 1552: ; 5/12/20: 0%->80; 5/12/20: FCD:17/12/2020->03/20; 19/3/21: 80%->100 / Impacted TSs and TRs: 33.501
- 1553: Impacted TSs and TRs: 33.501
- 1554: 11/6/21: 0%->25; 13/9/21: 25%->70; 1/10/21: 33.881 added;; 4/6/22: 70%->100 / Impacted TSs and TRs: 33.881
- 1555: ; 12/3/22: FCD:12/12/2021->3/22; 12/3/22: 0%->100 / Impacted TSs and TRs: 33.501
- 1556: ; 22/3/22: 0%->100 / Impacted TSs and TRs: 24.302; 24.368; 24.501; 24.502; 29.503; 29.509; 29.273; 29.510; 31.102; 31.111; 31.101
- 1557: ; 12/3/22: 0%->98; 4/6/22: 98%->100 / Impacted TSs and TRs: 24.302; 24.368; 24.501; 24.502; 29.503; 29.509; 29.273; 29.510; 31.102; 31.111; 31.101
- 1558: ; 12/3/22: 0%->100; 4/6/22: 100%-> / Impacted TSs and TRs: 24.302; 24.368; 24.501; 24.502; 29.503; 29.509; 29.273; 29.510; 31.102; 31.111; 31.101
- 1559: 19/3/21: FCD:12/06/2021->03/22; 19/3/21: 0%->5; 11/6/21: 5%->20; 13/9/21: 20%->87; 12/3/22: 87%->98; 12/3/22: FCD:11/03/2022->06/22; 4/6/22: 98%->100 / Impacted TSs and TRs: 33.107; 33.108; 33.126; 33.127; 33.128
- 1560: 19/3/21: FCD:12/06/2021->03/22; 19/3/21: 0%->5; 11/6/21: 5%->20; 13/9/21: 20%->87; 12/3/22: 87%->98; 12/3/22: FCD:11/03/2022->06/22; 4/6/22: 98%->100 / Impacted TSs and TRs: 33.107; 33.108; 33.126; 33.127; 33.128
- 1564: 19/3/21: 0%->100 / Impacted TSs and TRs: 23.228
- 1565: 19/3/21: 0%->100 / Impacted TSs and TRs: 23.228
- 1566: ; 12/3/22: 70%->100 / Impacted TSs and TRs: 24.229
- 1568: 23.501, 23.502 ; 19/3/21: 0%->100
- 1570: 11/6/21: 0%->98; 11/6/21: FCD:Fri 11/06/->09/21; 11/6/21: WID:CP-210071->CP-211184; 13/9/21: 98%->100 / Impacted TSs and TRs: 29.513
- 1571: 11/6/21: 0%->80; 13/9/21: 80%->100 / Impacted TSs and TRs: 29.502; 29.503; 29.504

| ID | WBS | Task | Duration | Start | Finish | Complete | Constraint | Resources | Work | Actual work | Acronym | PCG approved | WI rapporteur name | WI rapporteur e-mail | Release | TSG approved |
| --- | --- | --- | --- | --- | --- | --- | --- | --- | --- | --- | --- | --- | --- | --- | --- | --- |
| 1572 | 719.3 | **System enhancement for Redundant PDU Session** | 514d | 2020-03-25 A | 2022-03-11 A | 100% |  |  | 4656h | 4656h | TEI17_SE_RPS | 45 | Devaki Chandramouli | devaki.chandraouli@nokia.com | Rel-17 | 88 |
| 1573 | 719.3.1 | Stage 2 for TEI17_SE_RPS | 58d | 2020-03-25 A | 2020-06-12 A | 100% | finish no earlier than 2020-06-12 | S2 | 464h | 464h | TEI17_SE_RPS | 45 | Devaki Chandramouli | devaki.chandraouli@nokia.com | Rel-17 | 88 |
| 1574 | 719.3.2 | **CT aspects of TEI17_SE_RPS** | 132d | 2021-09-10 A | 2022-03-11 A | 100% |  | ct | 4192h | 4192h | TEI17_SE_RPS | 47 | WON, Sung Hwan, Nokia | sung.won@nokia.com | Rel-17 | 93 |
| 1575 | 719.3.2.1 | CT1 aspects of TEI17_SE_RPS | 131d | 2021-09-10 A | 2022-03-11 A | 100% | finish no earlier than 2022-03-12 | C1 | 1048h | 1048h | TEI17_SE_RPS | 47 | WON, Sung Hwan, Nokia | sung.won@nokia.com | Rel-17 | 93 |
| 1576 | 719.3.2.2 | CT3 aspects of TEI17_SE_RPS | 131d | 2021-09-10 A | 2022-03-11 A | 100% | finish no earlier than 2022-03-12 | C3 | 1048h | 1048h | TEI17_SE_RPS | 47 | WON, Sung Hwan, Nokia | sung.won@nokia.com | Rel-17 | 93 |
| 1577 | 719.3.2.3 | CT4 aspects of TEI17_SE_RPS | 131d | 2021-09-10 A | 2022-03-11 A | 100% | finish no earlier than 2022-03-12 | C4 | 1048h | 1048h | TEI17_SE_RPS | 47 | WON, Sung Hwan, Nokia | sung.won@nokia.com | Rel-17 | 93 |
| 1578 | 719.4 | **Support for Signed Attestation for Priority and Emergency Sessions** | 383d | 2020-03-25 A | 2021-09-10 A | 100% |  |  | 3488h | 3488h | TEI17_SAPES | 44 | Foti, George, Ericsson | George.foti@ericsson.com | Rel-17 | 87 |
| 1579 | 719.4.1 | Stage 2 for TEI17_SAPES | 58d | 2020-03-25 A | 2020-06-12 A | 100% | finish no earlier than 2020-06-12 | S2 | 464h | 464h | TEI17_SAPES | 44 | Foti, George, Ericsson | George.foti@ericsson.com | Rel-17 | 87 |
| 1580 | 719.4.2 | **CT aspects on TEI17_SAPES** | 126d | 2021-03-19 A | 2021-09-10 A | 100% |  | ct | 3024h | 3024h | TEI17_SAPES | 46 | Axell, Jörgen, Ericsson | Jorgen.Axell@ericsson.com | Rel-17 | 91 |
| 1581 | 719.4.2.1 | CT1 aspects on TEI17_SAPES | 126d | 2021-03-19 A | 2021-09-10 A | 100% | finish no earlier than 2021-09-12 | C1 | 1008h | 1008h | TEI17_SAPES | 46 | Axell, Jörgen, Ericsson | Jorgen.Axell@ericsson.com | Rel-17 | 91 |
| 1582 | 719.4.2.2 | CT3 aspects on TEI17_SAPES | 126d | 2021-03-19 A | 2021-09-10 A | 100% | finish no earlier than 2021-09-12 | C3 | 1008h | 1008h | TEI17_SAPES | 46 | Axell, Jörgen, Ericsson | Jorgen.Axell@ericsson.com | Rel-17 | 91 |
| 1583 | 719.5 | **Dynamically Changing AM Policies in the 5GC** | 524d | 2020-03-11 A | 2022-03-11 A | 100% |  |  | 6760h | 6760h | TEI17_DCAMP | 44 | Pancorbo, Belen (Ericsson) |  | Rel-17 | 87 |
| 1584 | 719.5.1 | Stage 2 for TEI17_DCAMP | 77d | 2020-03-11 A | 2020-06-25 A | 100% | finish no earlier than 2020-06-25 | S2 | 616h | 616h | TEI17_DCAMP | 44 | Pancorbo, Belen (Ericsson) |  | Rel-17 | 87 |
| 1585 | 719.5.2 | **CT aspects on TEI17_DCAMP** | 257d | 2021-03-19 A | 2022-03-11 A | 100% |  | ct | 6144h | 6144h | TEI17_DCAMP | 46 | Garcia Azorero, Fuencisla. Ericsson | fuencisla.garcia@ericsson.com | Rel-17 | 91 |
| 1586 | 719.5.2.1 | CT3 aspects on TEI17_DCAMP | 256d | 2021-03-19 A | 2022-03-11 A | 100% | finish no earlier than 2022-03-12 | C3 | 2048h | 2048h | TEI17_DCAMP | 46 | Garcia Azorero, Fuencisla. Ericsson | fuencisla.garcia@ericsson.com | Rel-17 | 91 |
| 1587 | 719.5.2.2 | CT4 aspects on TEI17_DCAMP | 256d | 2021-03-19 A | 2022-03-11 A | 100% | finish no earlier than 2022-03-12 | C4 | 2048h | 2048h | TEI17_DCAMP | 46 | Garcia Azorero, Fuencisla. Ericsson | fuencisla.garcia@ericsson.com | Rel-17 | 91 |
| 1588 | 719.6 | IP address pool information from UDM | 77d | 2020-03-11 A | 2020-06-25 A | 100% | finish no earlier than 2020-06-25 | S2 | 616h | 616h | TEI17_IPU | 44 | Stefan Rommer | stefan . rommer @ ericsson . com | Rel-17 | 87 |
| 1589 | 719.7 | **Dynamic management of group-based event monitoring** | 524d | 2020-03-11 A | 2022-03-11 A | 100% |  |  | 6760h | 6760h | TEI17_GEM | 44 | Qian XB Chen, Ericsson | Qian.XB.Chen@ericsson.com | Rel-17 | 87 |
| 1590 | 719.7.1 | Stage 2 for TEI17_GEM | 77d | 2020-03-11 A | 2020-06-25 A | 100% | finish no earlier than 2020-06-25 | S2 | 616h | 616h | TEI17_GEM | 44 | Qian XB Chen, Ericsson | Qian.XB.Chen@ericsson.com | Rel-17 | 87 |
| 1591 | 719.7.2 | **CT aspects on TEI17_GEM** | 257d | 2021-03-19 A | 2022-03-11 A | 100% |  | ct | 6144h | 6144h | TEI17_GEM | 46 | Maria Tianmei, Liang, Ericsson | maría.liang@ericsson.com | Rel-17 | 91 |
| 1592 | 719.7.2.1 | CT3 aspects on TEI17_GEM | 256d | 2021-03-19 A | 2022-03-11 A | 100% | finish no earlier than 2022-03-12 | C3 | 2048h | 2048h | TEI17_GEM | 46 | Maria Tianmei, Liang, Ericsson | maría.liang@ericsson.com | Rel-17 | 91 |
| 1593 | 719.7.2.2 | CT4 aspects on TEI17_GEM | 256d | 2021-03-19 A | 2022-03-11 A | 100% | finish no earlier than 2022-03-12 | C4 | 2048h | 2048h | TEI17_GEM | 46 | Maria Tianmei, Liang, Ericsson | maría.liang@ericsson.com | Rel-17 | 91 |
| 1594 | 719.8 | **Support of different slices over different Non 3GPP access** | 333d | 2020-03-11 A | 2021-06-18 A | 100% |  |  | 712h | 712h | TEI17_N3SLICE | 44 | Laurent Thiebaut, Nokia | Laurent.thiebaut@nokia.com | Rel-17 | 87 |
| 1595 | 719.8.1 | Stage 2 for TEI17_N3SLICE | 77d | 2020-03-11 A | 2020-06-25 A | 100% | finish no earlier than 2020-06-25 | S2 | 616h | 616h | TEI17_N3SLICE | 44 | Laurent Thiebaut, Nokia | Laurent.thiebaut@nokia.com | Rel-17 | 87 |
| 1596 | 719.8.2 | CT1 aspects of TEI17_N3SLICE | 6d | 2021-06-11 A | 2021-06-18 A | 100% | finish no earlier than 2021-06-20 | C1 | 48h | 48h | TEI17_N3SLICE | 47 | LANDAIS, Bruno, Nokia | bruno.landais@nokia.com | Rel-17 | 92 |
| 1597 | 719.8.3 | CT4 aspects of TEI17_N3SLICE | 6d | 2021-06-11 A | 2021-06-18 A | 100% | finish no earlier than 2021-06-20 | C4 | 48h | 48h | TEI17_N3SLICE | 47 | LANDAIS, Bruno, Nokia | bruno.landais@nokia.com | Rel-17 | 92 |

Notes:
- 1572: ; 11/6/21: 0%->100 / Impacted TSs and TRs: 23.501; 23.502
- 1573: ; 11/6/21: 0%->100 / Impacted TSs and TRs: 23.501; 23.502
- 1574: Impacted TSs and TRs: 24.501; 24.526; 27.007; 29.513; 29.525; 29.561; 29.502
- 1575: ; 13/12/21: 0%->100 / Impacted TSs and TRs: 24.501; 24.526; 27.007
- 1576: ; 13/12/21: 0%->50; 12/3/22: 50%->100 / Impacted TSs and TRs: 29.513; 29.525; 29.561
- 1577: ; 13/12/21: 0%->100 / Impacted TSs and TRs: 29.502
- 1579: 19/3/21: 0%->100 / Impacted TSs and TRs: 23.228; 23.167
- 1580: Impacted TSs and TRs: 24.229; 29.165
- 1581: ; 11/6/21: 0%->100
- 1582: ; 11/6/21: 0%->100
- 1584: 19/3/21: 0%->100 / Impacted TSs and TRs: 23.501; 23.502; 23.503
- 1585: ; 11/6/21: WID:CP-210291->CP-211192; 10/9/21: WID:CP-211192->CP-212163 / Impacted TSs and TRs: 29.513; 29.507; 29.512; 29.519; 29.521; 29.523; 29.514; 29.504; 29.510; 29.522; 29.571
- 1586: ; 11/6/21: 0%->30; 13/9/21: 30%->50; 13/12/21: 50%->75; 12/3/22: 75%->100
- 1587: ; 13/12/21: 0%->70; 12/3/22: 70%->100
- 1588: 19/3/21: 0%->100
- 1590: 11/6/21: 0%->100 / Impacted TSs and TRs: 23.682
- 1591: ; 11/6/21: WID:CP-210185->CP-211195; 10/9/21: WID:CP-211195->CP-212165 / Impacted TSs and TRs: 29.122 29.336
- 1592: ; 11/6/21: 0%->35; 13/9/21: 35%->80; 13/12/21: 80%->90; 12/3/22: 90%->100
- 1593: ; 13/9/21: 0%->80; 7/1/22: 80%->90; 12/3/22: 90%->100
- 1594: 19/3/21: 0%->100 / Impacted TSs and TRs: 23.501; 23.502
- 1595: 19/3/21: 0%->100 / Impacted TSs and TRs: 23.501; 23.502
- 1596: ; 11/6/21: 0%->100; 1/10/21: 0%->100 / Impacted TSs and TRs: 24.501;29.571;29.510
- 1597: ; 11/6/21: 0%->100 / Impacted TSs and TRs: 24.501;29.571;29.510

| ID | WBS | Task | Type | Duration | Start | Finish | Complete | Remaining | Total slack | Constraint | Resources | Work | Actual work | Acronym | PCG approved | WI rapporteur name | WI rapporteur e-mail | Release | TSG approved | Status Report |
| --- | --- | --- | --- | --- | --- | --- | --- | --- | --- | --- | --- | --- | --- | --- | --- | --- | --- | --- | --- | --- |
| 1598 | 719.9 | **N7/N40 Interfaces Enhancements to Support GERAN and UTRAN** |  | 393d | 2020-03-11 A | 2021-09-10 A | 100% |  |  |  |  | 4680h | 4680h | TEI17_NIESGU | 44 | Aihua, Li, China Mobile | liaihua@ chinamobile.com | Rel-17 | 87 |  |
| 1599 | 719.9.1 | Stage 2 for TEI17_NIESGU |  | 77d | 2020-03-11 A | 2020-06-25 A | 100% |  |  | finish no earlier than 2020-06-25 | S2 | 616h | 616h | TEI17_NIESGU | 44 | Aihua, Li, China Mobile | liaihua@ chinamobile.com | Rel-17 | 87 |  |
| 1600 | 719.9.2 | SA5 aspects of N40 Interface Enhancements to Support GERAN and UTRAN |  | 256d | 2020-09-16 A | 2021-09-08 A | 100% |  |  | finish no earlier than 2021-09-08 | S5 | 2048h | 2048h | TEI17_NIESGU | 45 | Dong, Jia, China Mobile | dongjia@chinamobile.com | Rel-17 | 89 |  |
| 1601 | 719.9.3 | CT3 aspects of N7 Interfaces Enhancements to Support GERAN and UTRAN |  | 126d | 2021-03-19 A | 2021-09-10 A | 100% |  |  | finish no earlier than 2021-09-12 | C3 | 1008h | 1008h | TEI17_NIESGU | 46 | Huang Zhenning (China Mobile) | huangzhenning (at) chinamobile (dot) com | Rel-17 | 91 |  |
| 1602 | 719.9.4 | CT4 aspects of N7 Interfaces Enhancements to Support GERAN and UTRAN |  | 126d | 2021-03-19 A | 2021-09-10 A | 100% |  |  | finish no earlier than 2021-09-12 | C4 | 1008h | 1008h | TEI17_NIESGU | 47 | Huang Zhenning (China Mobile) | huangzhenning (at) chinamobile (dot) com | Rel-17 | 92 |  |
| 1603 | 720 | (Small) Test Technical Enhancements and Improvements for Rel-17 |  | 73d | 2021-12-10 A | 2022-03-22 A | 100% |  |  | finish no earlier than 2022-03-22 | R5 | 584h | 584h | TEI17_Test | 48 |  |  | Rel-17 | 95 |  |
| 1604 | 721 | **Stage-3 5GS NAS protocol development 17** |  | 448d | 2020-06-25 A | 2022-03-11 A | 100% |  |  |  | C1 | 9736h | 9736h | 5GProtoc17 | 45 | Sedlacek, Ivo, Ericsson | ivo <dot> sedlacek <at> ericsson <dot> com | Rel-17 | 88 |  |
| 1605 | 721.1 | Stage-3 5GS NAS protocol development 17 general aspects |  | 447d | 2020-06-25 A | 2022-03-11 A | 100% |  |  | finish no earlier than 2022-03-12 | C1 | 3576h | 3576h | 5GProtoc17 | 45 | Sedlacek, Ivo, Ericsson | ivo <dot> sedlacek <at> ericsson <dot> com | Rel-17 | 88 |  |
| 1606 | 721.2 | Stage-3 5GS NAS protocol development 17 non-IETF aspects |  | 323d | 2020-06-25 A | 2021-09-20 A | 100% |  |  | finish no earlier than 2021-09-20 | C1 | 2584h | 2584h | 5GProtoc17-non3GPP | 45 | Sedlacek, Ivo, Ericsson | ivo <dot> sedlacek <at> ericsson <dot> com | Rel-17 | 88 |  |
| 1607 | 722 | **Stage-3 SAE Protocol Development** |  | 448d | 2020-06-25 A | 2022-03-11 A | 100% |  |  |  | C1 | 12320h | 12320h | SAES17 | 45 | Aghili, Behrouz, InterDigital Communications | behrouz.aghili@interdigital.com | Rel-17 | 88 |  |
| 1608 | 722.1 | Stage-3 SAE Protocol Development general aspects |  | 447d | 2020-06-25 A | 2022-03-11 A | 100% |  |  | finish no earlier than 2022-03-12 | C1 | 3576h | 3576h | SAES17 | 45 | Aghili, Behrouz, InterDigital Communications | behrouz.aghili@interdigital.com | Rel-17 | 88 |  |
| 1609 | 722.2 | Stage-3 SAE Protocol Development CSFB aspects |  | 323d | 2020-06-25 A | 2021-09-20 A | 100% |  |  | finish no earlier than 2021-09-20 | C1 | 2584h | 2584h | SAES17-CSFB | 45 | Aghili, Behrouz, InterDigital Communications | behrouz.aghili@interdigital.com | Rel-17 | 88 |  |
| 1610 | 722.3 | Stage-3 SAE Protocol Development non 3GPP aspects |  | 323d | 2020-06-25 A | 2021-09-20 A | 100% |  |  | finish no earlier than 2021-09-20 | C1 | 2584h | 2584h | SAES17-non3GPP | 45 | Aghili, Behrouz, InterDigital Communications | behrouz.aghili@interdigital.com | Rel-17 | 88 |  |
| 1611 | 723 | **IMS Stage-3 IETF Protocol Alignment** |  | 1102d | 2020-06-25 A | 2024-09-09 | 75% | 274.55d | 386d |  | ct | 18616h | 10728h | IMSProtoc17 | 45 | Gkatzikis, Lazaros(Nokia) | lazaros(dot)gkatzikis(at)nokia(dot)com | Rel-17 | 88 |  |
| 1612 | 723.1 | CT1 aspects of IMS Stage-3 IETF Protocol Alignment |  | 447d | 2020-06-25 A | 2022-03-11 A | 100% |  |  | finish no earlier than 2022-03-12 | C1 | 3576h | 3576h | IMSProtoc17 | 45 | Gkatzikis, Lazaros(Nokia) | lazaros(dot)gkatzikis(at)nokia(dot)com | Rel-17 | 88 |  |
| 1613 | 723.2 | CT3 aspects of IMS Stage-3 IETF Protocol Alignment |  | 447d | 2020-06-25 A | 2022-03-11 A | 100% |  |  | finish no earlier than 2022-03-12 | C3 | 3576h | 3576h | IMSProtoc17 | 45 | Gkatzikis, Lazaros(Nokia) | lazaros(dot)gkatzikis(at)nokia(dot)com | Rel-17 | 88 |  |
| 1614 | 723.3 | UE Conformance - IMS Data Channel |  | 332d | 2023-06-07 A | 2024-09-09 | 8% | 305.44d | 386d | finish no earlier than 2024-09-09 | R5 | 2656h |  | IMSProtoc17_dataCH-UEContest | 51 | Zhaobing Yang, Huawei Technologies. Co., Ltd | yangzhaobing@huawei.com | Rel-17 | 100 | RP-240282 |
| 1615 | 724 | Packet Flow Description (PFD) management enhancement |  | 252d | 2020-06-25 A | 2021-06-11 A | 100% |  |  | finish no earlier than 2021-06-12 | C3 | 2016h | 2016h | pfdManEnh | 45 | Xiaoyun Zhou, Huawei | zhouxiaoyun8@huawei.com | Rel-17 | 88 |  |
| 1616 | 725 | **Service Based Interface Protocol Improvements Release 17** |  | 448d | 2020-06-25 A | 2022-03-11 A | 100% |  |  |  |  | 7152h | 7152h | SBIProtoc17 | 45 | Song Yue, China Mobile | songyue@chinamobile.com | Rel-17 | 88 |  |
| 1617 | 725.1 | CT3 aspects of SBIProtoc17 |  | 447d | 2020-06-25 A | 2022-03-11 A | 100% |  |  | finish no earlier than 2022-03-12 | C3 | 3576h | 3576h | SBIProtoc17 | 45 | Song Yue, China Mobile | songyue@chinamobile.com | Rel-17 | 88 |  |
| 1618 | 725.2 | CT4 aspects of SBIProtoc17 |  | 447d | 2020-06-25 A | 2022-03-11 A | 100% |  |  | finish no earlier than 2022-03-11 | C4 | 3576h | 3576h | SBIProtoc17 | 45 | Song Yue, China Mobile | songyue@chinamobile.com | Rel-17 | 88 |  |
| 1619 | 726 | Study on restoration of profiles related to UDR |  | 330d | 2020-12-07 A | 2022-03-11 A | 100% |  |  | finish no earlier than 2022-03-12 | C4 | 2640h | 2640h | FS_ReP_UDR | 46 | Ishikawa, Hiroshi, NTT DOCOMO | hiroshi.ishikawa.ev (at) nttdocomo.com | Rel-17 | 90 |  |
| 1620 | 727 | **Restoration of Profiles related to UDR** |  | 793d | 2019-03-07 A | 2022-03-18 A | 100% |  |  |  | C4 | 19008h | 19008h | ReP_UDR | 48 | Ishikawa, Hiroshi, NTT DOCOMO | hiroshi.ishikawa.ev (at) nttdocomo.com | Rel-17 | 94 |  |
| 1621 | 727.1 | CT3 aspects of ReP_UDR |  | 792d | 2019-03-07 A | 2022-03-18 A | 100% |  |  | finish no earlier than 2022-03-18 | C3 | 6336h | 6336h | ReP_UDR | 49 | Ishikawa, Hiroshi, NTT DOCOMO | hiroshi.ishikawa.ev (at) nttdocomo.com | Rel-17 | 97 |  |
| 1622 | 727.2 | CT4 aspects of ReP_UDR |  | 792d | 2019-03-07 A | 2022-03-18 A | 100% |  |  | finish no earlier than 2022-03-18 | C4 | 6336h | 6336h | ReP_UDR | 49 | Ishikawa, Hiroshi, NTT DOCOMO | hiroshi.ishikawa.ev (at) nttdocomo.com | Rel-17 | 97 |  |
| 1623 | 728 | Multi-device enhancements for device transfers |  | 131d | 2021-12-10 A | 2022-06-10 A | 100% |  |  | finish no earlier than 2022-06-12 | C1 | 1048h | 1048h | MuDTran | 48 | Axell, Jörgen, Ericsson | Jorgen.Axell@ericsson.com | Rel-17 | 94 |  |
| 1624 | 729 | Enhancement on the GTP-U entity restart |  | 66d | 2021-12-10 A | 2022-03-11 A | 100% |  |  | finish no earlier than 2022-03-12 | C4 | 528h | 528h | EGTPUR | 48 | YONG, YANG, Ericsson | frank.yong.yang@ericsson.com | Rel-17 | 94 |  |
| 1625 | 730 | Study on authentication enhancements in 5GS |  | 782d | 2018-12-13 A | 2021-12-10 A | 100% |  |  | finish no earlier than 2021-12-12 | S3 | 6256h | 6256h | FS_AUTH_ENH | 42 | Tsiatsis, Vlasios, | vlasios.tsiatsis@ericsson.com | Rel-17 | 82 |  |
| 1626 | 731 | Authentication enhancements in 5GS |  | 66d | 2021-12-10 A | 2022-03-11 A | 100% |  |  | finish no earlier than 2022-03-12 | S3 | 528h | 528h | AUTH_ENH | 48 | Tsiatsis, Vlasios, Ericsson | vlasios.tsiatsis@ericsson.com | Rel-17 | 94 |  |
| 1627 | 732 | Repository for the 3GPP Allocated Port Numbers for New 3GPP Interfaces |  | 2d | 2022-03-10 A | 2022-03-11 A | 100% |  |  | finish no earlier than 2022-03-12 | C4 | 16h | 16h | PortAl | 48 | Giorgi Gulbani, Huawei | giorgi.gulbani@huawei.com | Rel-17 | 95 |  |
| 1628 | 733 | Modifying PASSporT signing and verification for Spoofed calls |  | 2d | 2022-03-10 A | 2022-03-11 A | 100% |  |  | finish no earlier than 2022-03-12 | C1 | 16h | 16h | SPECTRE_Ph3 | 48 | Politz, Ken, Neustar | ken.politz@team.neustar | Rel-17 | 95 |  |
| 1629 | 734 | Update of conformance test specifications to Rel-17 |  | 788d | 2021-06-14 A | 2024-06-14 A | 100% |  |  | finish no earlier than 2024-06-14 | C6 | 6304h | 6304h | UEConTest_R17 | 47 | Arne Marquordt, COMPRION GmbH | amarquordt@comprion.com | Rel-17 | 92 |  |
| 1630 | 735 | Rel-17 Management-only Features | milestone, manual | 0d | 2016-06-09 A | 2016-06-09 A | 100% |  |  | finish no earlier than 2016-06-09 |  |  |  |  |  |  |  | Rel-17 |  |  |
| 1631 | 736 | Management Aspects of 5G Network Sharing |  | 331d | 2020-12-04 A | 2022-03-11 A | 100% |  |  | finish no earlier than 2022-03-12 | S5 | 2648h | 2648h | MANS | 46 | Mingrui Sun, China Unicom | sunmr19@chinaunicom.cn | Rel-17 | 90 |  |
| 1632 | 737 | Study on Management Aspects of 5G Network Sharing |  | 131d | 2021-06-11 A | 2021-12-10 A | 100% |  |  | finish no earlier than 2021-12-12 | S5 | 1048h | 1048h | FS_MANS | 47 | Mingrui Sun, China Unicom | sunmr19@chinaunicom.cn | Rel-17 | 92 |  |
| 1633 | 738 | File Management |  | 257d | 2021-03-18 A | 2022-03-11 A | 100% |  |  | finish no earlier than 2022-03-12 | S5 | 2056h | 2056h | FIMA | 46 | Pollakowski, Olaf, Nokia | olaf.pollakowski@nokia.com | Rel-17 | 91 |  |

Notes:
- 1599: 11/6/21: 0%->100 / Impacted TSs and TRs: 23.060; 23.401; 23.503; 23.203
- 1600: 25/09/20: acronym: "NIESGU"->"TEI17_NIESGU"; 25/9/20: WID:SP-200768->SP-200854; 5/12/20: FCD:11/06/2021->09/20; 5/12/20: 0%->5; 21/3/21: 5%->10; 13/9/21: 10%->100 / Impacted TSs and TRs: 32.240; 32.251; 32.255; 32.290; 32.291; 32.298
- 1601: ; 11/6/21: 0%->90; 11/6/21: WID:CP-210186->CP-211194; 13/9/21: 90%->100 / Impacted TSs and TRs: 29.512; 29.513
- 1602: 2/7/21: added; 13/9/21: 0%->100 / Impacted TSs and TRs: 29.512; 29.513
- 1603: Added as per Ingo's request on 02/04/22
- 1604: Impacted TSs and TRs: 23.040; 23.041; 23.122; 24.007; 24.008; 24.011; 24.173; 24.229; 24.301; 24.302; 24.305; 24.341; 24.368; 24.501; 24.502; 24.526; 27.007
- 1605: 23.040; 23.041; 23.122; 24.007; 24.008; 24.011; 24.173; 24.229; 24.301; 24.302; 24.305; 24.341; 24.368; 24.501; 24.502; 24.526; 27.007 ; 13/9/20: 0%->10; 5/12/20: 10%->30; 21/3/21: 30%->40; 11/6/21: 40%->50; 13/9/21: 50%->70; 13/9/21: FCD:Mon 20/09/->0
- 1606: 1/10/21: 0%->70; 23/9/22: 70%->100 / Impacted TSs and TRs: 23.040; 23.041; 23.122; 24.007; 24.008; 24.011; 24.173; 24.229; 24.301; 24.302; 24.305; 24.341; 24.368; 24.501; 24.502; 24.526; 27.007
- 1608: 13/9/20: 0%->10; 5/12/20: 10%->30; 21/3/21: 30%->40; 11/6/21: 40%->50; 13/9/21: 50%->65; 13/12/21: 65%->90; 12/3/22: FCD:20/09/2021->3/22; 12/3/22: 90%->100 / Impacted TSs and TRs: 23.122; 24.008; 24.167; 24.229; 24.301; 24.302; 24.303; 24.304; 24.305; 24.312; 29.018; 29.118; 24.368 ;
- 1609: 22/3/22: 0%->100 / Impacted TSs and TRs: 23.122; 24.008; 24.167; 24.229; 24.301; 24.302; 24.303; 24.304; 24.305; 24.312; 29.018; 29.118; 24.368
- 1610: 22/3/22: 0%->100 / Impacted TSs and TRs: 23.122; 24.008; 24.167; 24.229; 24.301; 24.302; 24.303; 24.304; 24.305; 24.312; 29.018; 29.118; 24.368
- 1611: 13/9/20: 0%->10; 13/9/20: 10%->15; 5/12/20: 15%->30; 21/3/21: 30%->20 / Impacted TSs and TRs: 23.218; 24.229; 24.930; 29.163; 29.165; 29.292 ;
- 1612: 11/6/21: 20%->40; 13/9/21: 40%->60; 13/12/21: 60%->80; 12/3/22: FCD:10/09/2021->3/22; 12/3/22: 80%->100 / Impacted TSs and TRs: 23.218; 24.229; 24.930; 29.163; 29.165; 29.292 ; 13/9/20: 0%->10; 13/9/20: 10%->15; 5/12/20: 15%->30; 21/3/21: 30%->20
- 1613: 11/6/21: 0%->60; 13/9/21: 60%->70; 13/12/21: 70%->85; 12/3/22: 85%->100; 12/3/22: FCD:10/09/2021->3/22 / Impacted TSs and TRs: 23.218; 24.229; 24.930; 29.163; 29.165; 29.292 ; 13/9/20: 0%->10; 13/9/20: 10%->15; 5/12/20: 15%->30; 21/3/21: 30%->20
- 1614: 6/9/23: FCD:12/12/2023->22/09/2023; Compl:0%->5%; Stat Rep: ->RP-232356; Rapporteur: HiSilicon->Zhaobing Yang, Huawei Technologies. Co., Ltd; Rap eMail: ->yangzhaobing@hisilicon.com; ; 6/10/23: WID:RP-231246->RP-232357; 8/12/23: FCD:22/09/2023->09/09/2...; 2/4/24: WID:RP-231246->RP-240283
- 1615: 13/9/20: 0%->25; 5/12/20: 25%->60; 21/3/21: 60%->98; 21/3/21: FCD:11/12/2020->06/21; 21/3/21: WID:CP-201208->CP-210183; 11/6/21: 98%->100 / Impacted TSs and TRs: 29.251; 29.551
- 1617: 13/9/20: 0%->15; 5/12/20: 15%->30; 21/3/21: 30%->50; 11/6/21: 50%->65; 11/6/21: WID:CP-201075->CP-211088; 13/9/21: 65%->75; 13/12/21: 75%->85; 12/3/22: FCD:20/09/2021->3/22; 12/3/22: 85%->100 / Impacted TSs and TRs: 29.507; 29.508; 29.512; 29.514; 29.519; 29.520; 29.521; 29.522; 29.523; 29.525; 29.551; 29.554; 29.554; 29.591; 29.594; 29.122; 29.222; 29.486; 29.517; 29.549; 29.675;
- 1618: 13/9/20: 0%->10; 5/12/20: 10%->20; 21/3/21: 20%->30; 11/6/21: 30%->50; 13/9/21: 50%->60; 13/12/21: 60%->80; 13/12/21: FCD:Mon 20/09/->03/22; 12/3/22: 80%->100 / Impacted TSs and TRs: 29.500; 29.501; 29.502; 29.503; 29.504; 29.505; 29.509; 29.510; 29.511; 29.515; 29.518; 29.531; 29.540; 29.541; 29.542; 29.544; 29.550; 29.562; 29.563; 29.571; 29.572; 29.573; 29.598;
- 1619: 21/3/21: 0%->20; 11/6/21: 20%->40; 13/9/21: FCD:Fri 10/09/->12/21; 13/9/21: 40%->60; 1/10/21: WID:CP-203019->CP-203271; 13/12/21: 60%->95; 12/3/22: FCD:10/12/2021->3/22; 12/3/22: 95%->100
- 1620: ; 12/3/22: 0%->100; 12/3/22: WID:CP-213070->CP-220100 / Impacted TSs and TRs: 23.527; 29.503; 29.505; 29.510; 29.519
- 1621: Impacted TSs and TRs: 23.527; 29.503; 29.505; 29.510; 29.519
- 1622: Impacted TSs and TRs: 23.527; 29.503; 29.505; 29.510; 29.519
- 1623: ; 12/3/22: 0%->90; 22/3/22: WID:CP-213080->CP-220352; 22/3/22: FCD:11/03/2022->06/22; 4/6/22: 90%->100 / Impacted TSs and TRs: 24.174; 24.175; 24.229
- 1624: ; 12/3/22: 0%->100 / Impacted TSs and TRs: 23.007; 23.527; 29.060; 29.244; 29.281
- 1625: 07/19: Rel corrected, was wrongly allocated to Rel-17¦20/3/19: 0%->5; 13/9/19: 5%->15; 13/9/19: FCD:19/09/2019->12/20; 19/9/19: WID:S3-183745->SP-190713; 6/12/19: 15%->40; 6/12/19: FCD:12/12/2019->03/20; 25/03/20: Rel-16->Rel-17; 26/6/20: FCD:12/03/202 / Impacted TSs and TRs: new
- 1626: ; 24/3/22: 0%->100 / Impacted TSs and TRs: 33.102
- 1627: ; 12/3/22: 0%->100 / Impacted TSs and TRs: 29.941
- 1628: ; 4/6/22: 0%->35; 20/6/22: Compl:35%->100% / Impacted TSs and TRs: 24.229
- 1629: Tests eV2XARC_Ph2;eCPSOR_CON;5G_ProSe;5GSAT_ARCH-CT;ING_5GS;MINT;NSWO_5G;ARCH_NR_REDCAP;IoT_SAT_ARCH_EPS / Impacted TSs and TRs: 31.121; 31.124
- 1630: Impacted TSs and TRs: 26.234; 26.247
- 1631: 32.130; 28.541; 28.552; 28.554 ; 21/3/21: 0%->20; 11/6/21: 20%->25; 13/9/21: 25%->30; 13/9/21: FCD:Fri 10/09/->03/22; 13/12/21: 30%->60; 12/3/22: 60%->100
- 1632: ; 13/9/21: 0%->5; 13/12/21: 5%->100 / Impacted TSs and TRs: New
- 1633: ; 11/6/21: 0%->25; 13/9/21: 25%->60; 13/12/21: 60%->75; 13/12/21: FCD:Fri 10/12/->03/22; 12/3/22: 75%->100 / Impacted TSs and TRs: 28.537; 28.622; 28.623; 28.532

| ID | WBS | Task | Type | Duration | Start | Finish | Complete | Remaining | Total slack | Constraint | Resources | Work | Actual work | Acronym | PCG approved | WI rapporteur name | WI rapporteur e-mail | Release | TSG approved | Status Report | TSG stopped |
| --- | --- | --- | --- | --- | --- | --- | --- | --- | --- | --- | --- | --- | --- | --- | --- | --- | --- | --- | --- | --- | --- |
| 1634 | 739 | **Improved support for NSA in the service-based management architecture** |  | 132d | 2021-09-10 A | 2022-03-11 A | 100% |  |  |  | S5 | 2096h | 2096h | NSA_SBMA | 46 | Lan Zou, Huawei | zoulan@huawei.com | Rel-17 | 91 |  |  |
| 1635 | 739.1 | Improved support for NSA in the service-based management architecture |  | 131d | 2021-09-10 A | 2022-03-11 A | 100% |  |  | finish no earlier than 2022-03-12 | S5 | 1048h | 1048h | NSA_SBMA | 47 | Lan Zou, Huawei | zoulan@huawei.com | Rel-17 | 93 |  |  |
| 1636 | 740 | Enhancement of Handover Optimization |  | 447d | 2020-06-25 A | 2022-03-11 A | 100% |  |  | finish no earlier than 2022-03-12 | S5 | 3576h | 3576h | E_HOO | 45 | Elmdahl, Per, Ericsson | per dot Elmdahl at Ericsson dot com | Rel-17 | 88 |  |  |
| 1637 | 741 | Management data collection control and discovery |  | 447d | 2020-06-25 A | 2022-03-11 A | 100% |  |  | finish no earlier than 2022-03-12 | S5 | 3576h | 3576h | MADCOL | 45 | Pollakowski, Olaf, Nokia | olaf.pollakowski@nokia.com | Rel-17 | 88 |  |  |
| 1638 | 742 | Management of the enhanced tenant concept |  | 384d | 2020-06-26 A | 2021-12-15 A | 100% |  |  | start no earlier than 2020-06-26 | S5 | 3072h | 3072h | eMEMTANE | 45 | Zhu, Lei, Huawei | lei.zhu@huawei.com | Rel-17 | 88 |  |  |
| 1639 | 743 | Enhancements of 5G performance measurements and KPIs |  | 456d | 2020-06-12 A | 2022-03-11 A | 100% |  |  | finish no earlier than 2022-03-12 | S5 | 3648h | 3648h | ePM_KPI_5G | 45 | Yizhi Yao, Intel | yizhi<dot>yao<at>intel<dot>com | Rel-17 | 88 |  |  |
| 1640 | 744 | Intent driven management service for mobile network |  | 917d? | 2018-09-06 A | 2022-03-11 A | 100% |  |  | finish no earlier than 2022-03-12 | S5 | 7336h | 7336h | IDMS_MN | 41 | Zou Lan, Huawei | zoulan@huawei.com | Rel-17 | 81 |  |  |
| 1641 | 745 | Discovery of management services in 5G |  | 847d | 2018-12-13 A | 2022-03-11 A | 100% |  |  | finish no earlier than 2022-03-12 | S5 | 6776h | 6776h | 5GDMS | 42 | Brendan Hassett, Huawei Technologies Sweden AB | brendan.t.hassett@huawei.com | Rel-17 | 82 |  |  |
| 1642 | 746 | Network policy managementfor 5G mobile networks |  | 591d | 2019-12-06 A | 2022-03-11 A | 100% |  |  | finish no earlier than 2022-03-12 | S5 | 4728h | 4728h | NPM | 44 | China Mobile Shasha Guo | guoshasha@chinamobile.com | Rel-17 | 86 |  |  |
| 1643 | 747 | Study on enhancement of Management Data Analytics Service |  | 387d | 2019-09-19 A | 2021-03-12 A | 100% |  |  | finish no earlier than 2021-03-12 | S5 | 3096h | 3096h | FS_eMDAS | 43 | Yao, Yizhi, Intel | yizhi.yao@intel.com | Rel-17 | 85 |  |  |
| 1644 | 748 | Enhancements of Management Data Analytics Service |  | 192d | 2021-03-18 A | 2021-12-10 A | 100% |  |  | finish no earlier than 2021-12-12 | S5 | 1536h | 1536h | eMDAS | 46 | Yao, Yizhi, Intel | yizhi<dot>yao<at>intel<dot>com | Rel-17 | 91 |  |  |
| 1645 | 749 | Enhancements on EE for 5G networks |  | 448d | 2020-03-25 A | 2021-12-10 A | 100% |  |  | finish no earlier than 2021-12-12 | S5 | 3584h | 3584h | EE5GPLUS | 44 | Jean-Michel CORNILY, ORANGE | jeanmichel.cornily@orange.com | Rel-17 | 87 |  |  |
| 1646 | 750 | Study on new aspects of EE for 5G networks |  | 448d | 2020-03-25 A | 2021-12-10 A | 100% |  |  | finish no earlier than 2021-12-12 | S5 | 3584h | 3584h | FS_EE5G | 44 | Jean-Michel CORNILY, ORANGE | jeanmichel.cornily@orange.com | Rel-17 | 87 |  |  |
| 1647 | 751 | Enhancement on Management Aspects of 5G Service-Level Agreement |  | 513d | 2020-03-25 A | 2022-03-11 A | 100% |  |  | finish no earlier than 2022-03-12 | S5 | 4104h | 4104h | EMA5SLA | 44 | SHI, Xiaonan, CMCC | shixiaonan@chinamobile.com | Rel-17 | 87 |  |  |
| 1648 | 752 | Management of MDT enhancement in 5G |  | 513d | 2020-03-25 A | 2022-03-11 A | 100% |  |  | finish no earlier than 2022-03-12 | S5 | 4104h | 4104h | e_5GMDT | 44 | Ayani, Zhulia, Ericsson | zhulia.Ayani@ericsson.com | Rel-17 | 87 |  |  |
| 1649 | 753 | Additional NRM features |  | 548d | 2020-02-05 A | 2022-03-11 A | 100% |  |  | finish no earlier than 2022-03-12 | S5 | 4384h | 4384h | adNRM | 44 | Sean Sun, Nokia | sean.sun@nokia-sbell.com | Rel-17 | 87 |  |  |
| 1650 | 754 | Enhanced Closed loop SLS Assurance |  | 513d | 2020-03-25 A | 2022-03-11 A | 100% |  |  | finish no earlier than 2022-03-12 | S5 | 4104h | 4104h | eCOSLA | 44 | Groenendijk, Jan, Ericsson | jan.groenendijk@ericsson.com | Rel-17 | 87 |  |  |
| 1651 | 755 | 5G Charging for Local breakout roaming of data connectivity |  | 67d | 2022-03-10 A | 2022-06-10 A | 100% |  |  | finish no earlier than 2022-06-12 | S5 | 536h | 536h | CHROAM | 48 | Ericsson, Robert Törnkvist | robert dot tornkvist at ericsson dot com | Rel-17 | 95 |  |  |
| 1652 | 756 | Rel-17 Other NR-only improvements | milestone, manual | 0d | 2016-06-09 A | 2016-06-09 A | 100% |  |  |  |  |  |  |  |  |  |  | Rel-17 |  |  |  |
| 1653 | 757 | Study on NR QoE (Quality of Experience) management and optimizations for diverse services |  | 197d | 2019-12-16 A | 2020-09-15 A | 100% |  |  | finish no earlier than 2020-09-15 | R3 | 1576h | 1576h | FS_NR_QoE | 44 | China Unicom |  | Rel-17 | 86 |  |  |
| 1654 | 758 | **NR QoE magement and optimizations for diverse services** |  | 966d | 2021-01-01 A | 2024-09-09 | 50% | 481.63d | 386d |  |  | 6752h | 2544h | NR_QoE | 46 | China Unicom |  | Rel-17 | 91 |  |  |
| 1655 | 758.1 | Core part: NR QoE management and optimizations for diverse services |  | 318d | 2021-01-01 A | 2022-03-22 A | 100% |  |  | finish no earlier than 2022-03-22 | R3 | 2544h | 2544h | NR_QoE-Core | 46 | Gen Cao | caogen@chinauincom.cn | Rel-17 | 91 | RP-220554 |  |
| 1656 | 758.2 | UE Conformance - NR QoE management and optimizations for diverse services |  | 526d | 2022-09-08 A | 2024-09-09 | 20% | 420.8d | 386d | finish no earlier than 2024-09-09 | R5 | 4208h |  | NR_QoE-UEConTest | 49 | Bo J NSSON, Ericsson | Bo[dot]jonsson[at]ericsson[dot]com | Rel-17 | 97 | RP-240073 |  |
| 1657 | 759 | **Rel-17 Power Class 2 UE for NR inter-band CA with or without SUL configurations with x (16>=x>2) bands DL and y (y=1, 2) bands UL** |  | 1110d | 2021-03-12 A | 2025-06-06 | 60% | 444.51d | 192d |  |  | 9544h | 5344h | NR_UE_PC2_R17_CADC_SUL_xBDL_yBUL | 46 | Huawei |  | Rel-17 | 91 |  |  |
| 1658 | 759.1 | Core part: NR_UE_PC2_R17_CADC_SUL_xBDL_yBUL |  | 334d | 2021-03-12 A | 2022-06-22 A | 100% |  |  | finish no earlier than 2022-06-22 | R4 | 2672h | 2672h | NR_UE_PC2_R17_CADC_SUL_xBDL_yBUL-Core | 46 | Wang, Jin, Huawei | jinwang@huawei.com | Rel-17 | 91 | RP-221515 |  |
| 1659 | 759.2 | Stopped - Perf. part: NR_UE_PC2_R17_CADC_SUL_xBDL_yBUL |  | 334d | 2021-03-12 A | 2022-06-22 A | 100% |  |  | finish no earlier than 2022-06-22 | R4 | 2672h | 2672h | NR_UE_PC2_R17_CADC_SUL_xBDL_yBUL-Perf | 46 | Wang, Jin, Huawei | jinwang@huawei.com | Rel-17 | 91 | RP-221515 | 96 |
| 1660 | 759.3 | UE Conformance - Rel-17 Power Class 2 UE for NR inter-band CA/DC with or without SUL configurations with x (6>=x>2) bands DL and y (y=1, 2) bands UL |  | 525d | 2023-06-08 A | 2025-06-06 | 9% | 477.75d | 192d | finish no earlier than 2025-06-06 | R5 | 4200h |  | NR_UE_PC2_R17_CADC_SUL_xBDL_yBUL-UEConTest | 51 | Yuxin Hao, Huawei Technologies. Co., Ltd. | haoyuxin@huawei.com | Rel-17 | 100 | RP-240278 |  |

Notes:
- 1634: Impacted TSs and TRs: 28.623; 28.622; 28.659; 28.663
- 1635: ; 13/12/21: 0%->20; 12/3/22: 20%->100 / Impacted TSs and TRs: 28.623; 28.622; 28.659; 28.663
- 1636: 28.552; 28.313; 28.541 ; 5/12/20: 0%->5; 21/3/21: 5%->10; 21/3/21: FCD:18/06/2021->03/22; 11/6/21: 10%->30; 13/9/21: 30%->40; 13/12/21: 40%->90; 12/3/22: 90%->100
- 1637: 28.533; 28.532; 28.622; 28.623 ; 5/12/20: 0%->5; 21/3/21: 5%->25; 11/6/21: 25%->30; 13/9/21: 30%->35; 13/9/21: FCD:Wed 22/09/->03/22; 13/12/21: 35%->40; 12/3/22: 40%->45; 4/6/22: 45%->100
- 1638: 28.531; 28.532; 28.533; 28.541 ; 5/12/20: 0%->5; 11/6/21: 5%->15; 13/9/21: 15%->20; 12/3/22: 20%->100; 22/3/22: WID:SP-200463->SP-220293
- 1639: 28.552; 32.425; 28.554; 32.426; 32.450; 32.451; 32.455 ; 13/9/20: 0%->10; 5/12/20: 10%->20; 21/3/21: 20%->40; 11/6/21: 40%->50; 13/9/21: 50%->60; 13/9/21: FCD:Fri 10/09/->03/22; 13/12/21: 60%->80; 12/3/22: 80%->100
- 1640: 7/12/18: 0%->20¦14/3/19: 20%->30; 31/5/19: 30%->35; 13/9/19: 35%->45; 13/9/19: FCD:14/06/2019->03/20; 26/3/20: 45%->55; 26/3/20: FCD:12/03/2020->03/21; Rel-16->Rel-17; 13/9/20: FCD:12/03/2021->09/21; 5/12/20: 55%->65; 21/3/21: 65%->70; 11/6/21: FCD:Wed / Impacted TSs and TRs: New
- 1641: ¦14/3/19: 0%->25; 31/5/19: 25%->35; 13/9/19: 35%->65; 13/9/19: FCD:19/06/2019->12/20; 26/3/20: 65%->80; 28/6/20: 80%->90. 09/20: moved from Rel-16; 13/9/20: WID:SP-181072->SP-200770; 13/9/20: FCD:12/12/2019->09/21; 25/9/20: 90%->50; 21/3/21: 50%->70; / Impacted TSs and TRs: 28.533; 28.532; 28.531
- 1642: ; 13/9/20: 0%->55; 13/9/20: FCD:11/12/2020->06/21; 5/12/20: 55%->60; 21/3/21: 60%->65; 21/3/21: FCD:11/06/2021->03/22. 9/4/21: corrected from Rel-16 to Rel-17; 11/6/21: 65%->75; 13/9/21: 75%->78; 13/12/21: 78%->100 / Impacted TSs and TRs: 28.532; 28.541
- 1643: ; 20/9/19: WID:SP-190783->SP-190930; 8/10/19: 28.809 added;; 26/3/20: 0%->30; 28/6/20: 30%->50; 13/9/20: 50%->70; 13/9/20: FCD:11/09/2020->03/21; 5/12/20: 70%->90; 21/3/21: 90%->100 / Impacted TSs and TRs: New ; 28.809
- 1644: ; 13/9/21: 0%->10; 13/9/21: FCD:Fri 10/12/->12/21; 13/12/21: 10%->45. UID was at 0, corrected; 12/3/22: 45%->65; 4/6/22: 65%->100 / Impacted TSs and TRs: 28.552; 32.425; 28.554; 28.541; 28.622; 28.623; 28.533; 28.105
- 1645: ; 13/9/20: FCD:16/06/2021->09/21; 5/12/20: 0%->10; 21/3/21: 10%->30; 11/6/21: 30%->55; 11/6/21: FCD:Wed 08/09/->12/21; 13/9/21: 55%->70; 13/12/21: 70%->100 / Impacted TSs and TRs: 28.310; 28.552; 28.554; 28.541
- 1646: 28/6/20: 0%->10; 13/9/20: 10%->25; 13/9/20: FCD:16/06/2021->09/21; 5/12/20: 25%->45; 21/3/21: 45%->70; 11/6/21: 70%->75; 11/6/21: FCD:Wed 08/09/->12/21; 13/9/21: 75%->80; 13/12/21: 80%->100
- 1647: ; 13/9/20: 0%->5; 5/12/20: 5%->40; 21/3/21: 40%->60; 21/3/21: FCD:18/03/2021->06/21; 11/6/21: 60%->65; 11/6/21: FCD:Fri 11/06/->12/21; 10/9/21: WID:SP-200190->SP-210860; 13/9/21: 65%->70; 13/12/21: 70%->85; 13/12/21: FCD:Fri 10/12/->03/22; 12/3/22: 85 / Impacted TSs and TRs: 28.541; 28.531
- 1648: ; 13/9/20: 0%->20; 5/12/20: 20%->50; 5/12/20: FCD:17/12/2020->06/20; 21/3/21: 50%->70; 21/3/21: FCD:11/06/2021->12/21; 11/6/21: 70%->75; 13/9/21: 75%->85; 13/12/21: 85%->95; 13/12/21: FCD:Fri 10/12/->03/22; 12/3/22: 95%->100 / Impacted TSs and TRs: 32.421; 32.422; 32.423; 28.622; 28.623; 28.523
- 1649: ; 10/6/20: FCD:19/03/2020->06/20; 5/12/20: 0%->5; 21/3/21: 5%->15; 11/6/21: 15%->30; 13/9/21: 30%->50; 13/9/21: FCD:Tue 15/06/->12/21; 13/12/21: 50%->80; 13/12/21: FCD:Fri 10/12/->03/22; 01/22: rapporteur change from Jing Ping; 12/3/22: 80%->100 / Impacted TSs and TRs: 28.540; 28.541; 28.622; 28.623
- 1650: 13/9/20: 0%->5; 5/12/20: 5%->10; 5/12/20: FCD:11/12/2020->03/20; 21/3/21: 10%->30; 11/6/21: 30%->50; 11/6/21: FCD:Fri 12/03/->09/21; 13/9/21: 50%->60; 13/9/21: FCD:Wed 08/09/->03/22; 13/12/21: 60%->80; 12/3/22: 80%->90; 4/6/22: 90%->100; 4/1/24: 28.867 added; / Impacted TSs and TRs: 28.535; 28.536; 28.533; 28.541; 28.546; 28.552; 28.553 ; 28.867
- 1651: 12/3/22: FCD:12/03/2022->6/22; 12/3/22: 0%->5; 4/6/22: 5%->100 / Impacted TSs and TRs: 32.240; 32.255; 32.290; 32.291; 32.298
- 1652: Impacted TSs and TRs: 26.234; 26.247
- 1653: affects: NR.; 25/9/20: 38.890 added;; 7/4/21: 0%->100 / Impacted TSs and TRs: 38.890
- 1654: follow-up WI of RAN3 REL-17 SI FS_NR_QoE; no Perf. part ; 2/7/21: WID:RP-210913->RP-211406
- 1655: follow-up WI of RAN3 REL-17 SI FS_NR_QoE; no Perf. part ; 20/6/22: FCD:31/12/2021->22/03/2022; Compl:0%->100%; Stat Rep: ->RP-220554; Rapporteur: China Unicom->Gen Cao; Rap eMail: ->caogen@chinauincom.cn;
- 1656: 9/12/22: FCD:08/09/2023->01/09/2023; Compl:0%->5%; Stat Rep: ->RP-222818; Rapporteur: Ericsson->Bo J NSSON, Ericsson; Rap eMail: ->Bo[dot]jonsson[at]ericsson[dot]com; 17/3/23: FCD:09/09/2023->08/09/2023; Stat Rep: RP-222818->RP-230267; ;...; 6/9/23: C...; 14/3/24: FCD:06/09/2024->09/09/2024; Stat Rep: RP-232955->RP-240073;
- 1657: basket WI; TR 38.8xx ; 2/7/21: WID:RP-210543->RP-211378; 29/9/21: WID:RP-211378->RP-212182; 6/1/22: WID:RP-212182->RP-213650; 5/4/22: WID:RP-213650->RP-220701; 12/7/22: WID:RP-220701->RP-221516
- 1658: basket WI; TR 38.8xx ; 2/7/21: 38.842 added;; 13/9/21: Compl:0%->5% ; 22/3/22: Compl:5%->78% ; 20/6/22: Rapporteur: Huawei->Wang, Jin, Huawei; Rap eMail: ->jinwang@huawei.com; / Impacted TSs and TRs: 38.842; 38.541
- 1659: ; 13/9/21: CD:Sat 12/03/22->Tue 22/03/22 ; 22/3/22: CD:22/03/2022->12/06/2022; 22/3/22: Stat Rep: RP-212181->RP-220699 ; 6/6/22: CD:12/06/2022->22/06/2022 ; 20/6/22:Stopped at 0%; Rapporteur: Huawei->Wang, Jin, Huawei; Rap eMail: ->jinwang@huawei.com;
- 1660: 6/9/23: FCD:06/06/2025->06/06/2024; Compl:0%->9%; Stat Rep: ->RP-232358; Rapporteur: Huawei->Yuxin Hao, Huawei Technologies. Co., Ltd.; Rap eMail: ->haoyuxin@huawei.com; ; 8/12/23: FCD:06/06/2024->06/06/2025; Stat Rep: RP-232358->RP-233766; ; 14/3/24: FCD:05/06/2025->06/06/2025; Stat Rep: RP-233766->RP-240278;

| ID | WBS | Task | Duration | Start | Finish | Complete | Constraint | Resources | Work | Actual work | Acronym | PCG approved | Impacted TSs and TRs | Release | TSG approved | Status Report |
| --- | --- | --- | --- | --- | --- | --- | --- | --- | --- | --- | --- | --- | --- | --- | --- | --- |
| 1661 | 760 | **Introduction of UE TRP (Total Radiated Power) and TRS (Total Radiated Sensitivity) requirements and test methodologies for FR1 (NR SA and EN-DC)** | 720d | 2021-03-12 A | 2023-12-12 A | 100% |  |  | 8472h | 8472h | NR_FR1_TRP_TRS | 46 | 38.161 | Rel-17 | 91 |  |
| 1662 | 760.1 | Core part: NR_FR1_TRP_TRS | 268d | 2021-03-12 A | 2022-03-22 A | 100% | finish no earlier than 2022-03-22 | R4 | 2144h | 2144h | NR_FR1_TRP_TRS-Core | 46 | 38.834 | Rel-17 | 91 | RP-221276 |
| 1663 | 760.2 | Perf. part: NR_FR1_TRP_TRS | 400d | 2021-03-12 A | 2022-09-22 A | 100% | finish no earlier than 2022-09-22 | R4 | 3200h | 3200h | NR_FR1_TRP_TRS-Perf | 46 |  | Rel-17 | 91 | RP-221276 |
| 1664 | 760.3 | UE Conformance - Introduction of UE TRP (Total Radiated Power) and TRS (Total Radiated Sensitivity) requirements and test methodologies for FR1 (NR SA and EN-DC) | 391d | 2022-06-15 A | 2023-12-12 A | 100% | finish no earlier than 2023-12-12 | R5 | 3128h | 3128h | NR_FR1_TRP_TRS-UEConTest | 49 | 38.561 | Rel-17 | 96 | RP-233311 |
| 1665 | 761 | **High power UE (power class 1.5) for NR band n79** | 451d | 2021-03-12 A | 2022-12-01 A | 100% |  |  | 4584h | 4584h | NR_UE_PC1_5_n79 | 46 |  | Rel-17 | 91 |  |
| 1666 | 761.1 | Core part: NR_UE_PC1_5_n79 | 129d | 2021-03-12 A | 2021-09-08 A | 100% | finish no earlier than 2021-09-08 | R4 | 1032h | 1032h | NR_UE_PC1_5_n79-Core | 46 |  | Rel-17 | 91 |  |
| 1667 | 761.2 | Perf. part: NR_UE_PC1_5_n79 | 129d | 2021-03-12 A | 2021-09-08 A | 100% | finish no earlier than 2021-09-08 | R4 | 1032h | 1032h | NR_UE_PC1_5_n79-Perf | 46 |  | Rel-17 | 91 |  |
| 1668 | 761.3 | UE Conformance - High power UE (power class 1.5) for NR band n79 | 315d | 2021-09-17 A | 2022-12-01 A | 100% | finish no earlier than 2022-12-01 | R5 | 2520h | 2520h | NR_UE_PC1_5_n79-UEConTest | 47 |  | Rel-17 | 93 | RP-223061 |
| 1669 | 762 | **High power UE (power class 2) for NR band n34** | 335d | 2021-03-12 A | 2022-06-22 A | 100% |  |  | 3656h | 3656h | NR_UE_PC2_n34 | 46 |  | Rel-17 | 91 |  |
| 1670 | 762.1 | Core part: NR_UE_PC2_n34 | 129d | 2021-03-12 A | 2021-09-08 A | 100% | finish no earlier than 2021-09-08 | R4 | 1032h | 1032h | NR_UE_PC2_n34-Core | 46 |  | Rel-17 | 91 |  |
| 1671 | 762.2 | Perf. part: NR_UE_PC2_n34 | 129d | 2021-03-12 A | 2021-09-08 A | 100% | finish no earlier than 2021-09-08 | R4 | 1032h | 1032h | NR_UE_PC2_n34-Perf | 46 |  | Rel-17 | 91 |  |
| 1672 | 762.3 | UE Conformance - High power UE (power class 2) for NR band n34 | 199d | 2021-09-17 A | 2022-06-22 A | 100% | finish no earlier than 2022-09-12 | R5 | 1592h | 1592h | NR_UE_PC2_n34-UEConTest | 47 |  | Rel-17 | 93 | RP-221357 |
| 1673 | 763 | **High power UE (power class 2) for NR band n39** | 663d | 2021-03-12 A | 2023-09-22 A | 100% |  |  | 6288h | 6288h | NR_UE_PC2_n39 | 46 |  | Rel-17 | 91 |  |
| 1674 | 763.1 | Core part: NR_UE_PC2_n39 | 129d | 2021-03-12 A | 2021-09-08 A | 100% | finish no earlier than 2021-09-08 | R4 | 1032h | 1032h | NR_UE_PC2_n39-Core | 46 |  | Rel-17 | 91 |  |
| 1675 | 763.2 | Perf. part: NR_UE_PC2_n39 | 129d | 2021-03-12 A | 2021-09-08 A | 100% | finish no earlier than 2021-09-08 | R4 | 1032h | 1032h | NR_UE_PC2_n39-Perf | 46 |  | Rel-17 | 91 |  |
| 1676 | 763.3 | UE Conformance - High power UE (power class 2) for NR band n39 | 528d | 2021-09-17 A | 2023-09-22 A | 100% | finish no earlier than 2023-09-22 | R5 | 4224h | 4224h | NR_UE_PC2_n39-UEConTest | 47 |  | Rel-17 | 93 | RP-232243 |
| 1677 | 764 | **Introduction of FR2 FWA (Fixed Wireless Access) UE with maximum TRP of 23dBm for band n259** | 129d | 2021-03-12 A | 2021-09-08 A | 100% |  |  | 2064h | 2064h | NR_FR2_FWA_Bn259 | 46 |  | Rel-17 | 91 |  |
| 1678 | 764.1 | Core part: NR_FR2_FWA_Bn259 | 129d | 2021-03-12 A | 2021-09-08 A | 100% | finish no earlier than 2021-09-08 | R4 | 1032h | 1032h | NR_FR2_FWA_Bn259-Core | 46 |  | Rel-17 | 91 |  |
| 1679 | 764.2 | Perf. part: NR_FR2_FWA_Bn259 | 129d | 2021-03-12 A | 2021-09-08 A | 100% | finish no earlier than 2021-09-08 | R4 | 1032h | 1032h | NR_FR2_FWA_Bn259-Perf | 46 |  | Rel-17 | 91 |  |
| 1680 | 765 | **NR Uplink Data Compression (UDC)** | 584d | 2021-03-12 A | 2023-06-06 A | 100% |  |  | 4128h | 4128h | NR_UDC | 46 |  | Rel-17 | 91 |  |
| 1681 | 765.1 | Core part: NR_UDC | 261d | 2021-03-12 A | 2022-03-11 A | 100% | finish no earlier than 2022-03-12 | R2 | 2088h | 2088h | NR_UDC-Core | 46 |  | Rel-17 | 91 | RP-220141 |
| 1682 | 765.2 | UE Conformance - NR Uplink Data Compression (UDC) | 255d | 2022-06-15 A | 2023-06-06 A | 100% | finish no earlier than 2023-06-06 | R5 | 2040h | 2040h | NR_UDC-UEConTest | 49 |  | Rel-17 | 96 | RP-230395 |
| 1683 | 766 | Study on optimizations of pi/2 BPSK uplink power in NR | 261d | 2021-03-12 A | 2022-03-11 A | 100% | finish no earlier than 2022-03-12 | R4 | 2088h | 2088h | FS_NR_Opt_pi2BPSK | 46 | 38.868 | Rel-17 | 91 | RP-220136 |
| 1684 | 767 | Study on band combination handling in RAN4 | 261d | 2021-03-12 A | 2022-03-11 A | 100% | finish no earlier than 2022-03-22 | R4 | 2088h | 2088h | FS_NR_ENDC_combo_rules | 46 | 38.862 | Rel-17 | 91 | RP-220164 |

Notes:
- 1661: compare LTE_UTRA_TRP_TRS; related to OTA; TR 38.8xx ; 2/7/21: WID:RP-210807->RP-211158; 29/9/21: WID:RP-211158->RP-212030; 1/10/21: 38.161 added;; / WI rapporteur name: Vivo
- 1662: compare LTE_UTRA_TRP_TRS; related to OTA; TR 38.8xx ; 2/7/21: 38.834 added ; 20/6/22: Rapporteur: Vivo->Wang, Ruixin; Liu, Qifei; Shaozhe, vivo, OPPO, CMCC; Rap eMail: ->ruixin.wang@vivo.com liuqifei@oppo.com shaozhe@CHINAMOBILE.COM; / WI rapporteur name: Wang, Ruixin; Liu, Qifei; Shaozhe, vivo, OPPO, CMCC / WI rapporteur e-mail: ruixin.wang@vivo.com liuqifei@oppo.com shaozhe@CHINAMOBILE.COM
- 1663: compare LTE_UTRA_TRP_TRS; related to OTA; TS 38.1yy ; 22/3/22: Compl:0%->20%; 22/3/22: CD:08/09/2022->12/09/2022 20/6/22: Rapporteur: Vivo->Wang, Ruixin; Liu, Qifei; Shaozhe, vivo, OPPO, CMCC; Rap eMail: ->ruixin.wang@vivo.com liuqifei@oppo.com s...; 23/9/22: WID:RP-221785->RP-222269 / WI rapporteur name: Wang, Ruixin; Liu, Qifei; Shaozhe, vivo, OPPO, CMCC / WI rapporteur e-mail: ruixin.wang@vivo.com liuqifei@oppo.com shaozhe@CHINAMOBILE.COM
- 1664: 9/9/22: Comp...; 23/9/22: 38.561 added;; 9/12/22: FCD:23/12/2022->01/12/2023; Compl:5%->9%; Stat Rep: ->RP-223197; Rapporteur: Apple->Ashwin Mohan, Jose Fortes, Ruixin Wang, Apple, Rohde and Schwarz, Vivo; Rap eMail: ->ashwin_mohan[at]apple...; 8/12/23: Compl:55%->100%; Stat Rep: RP-231968->RP-233311; / WI rapporteur name: Ashwin Mohan, Jose Fortes, Ruixin Wang, Apple, Rohde and Schwarz, Vivo / WI rapporteur e-mail: ashwin_mohan[at]apple.com, Jose.Fortes[at]rohde-schwarz.com,ruixin.wang[at]vivo.com
- 1665: WI rapporteur name: CMCC
- 1666: ; 29/9/21: 0%->100 / WI rapporteur name: CMCC
- 1667: ; 29/9/21: 0%->100 / WI rapporteur name: CMCC
- 1668: tested: REL-17 WI NR_UE_PC1_5_n79-Core ; 6/1/22: WID:RP-211979->RP-213033; 22/3/22: Compl:0%->57% ; 20/6/22: Rapporteur: CMCC->Dan SONG, CMCC; Rap eMail: ->songdan@chinamobile.com ; ;...; 9/12/22: FCD:23/03/2023->01/12/2022; Compl:84%->100%; Stat R...; 9/1/23: 100%->100 / WI rapporteur name: Dan SONG, CMCC / WI rapporteur e-mail: songdan@chinamobile.com
- 1669: WI rapporteur name: CMCC
- 1670: ; 2/7/21: 0%->100 / WI rapporteur name: CMCC
- 1671: ; 2/7/21: 0%->100 / WI rapporteur name: CMCC
- 1672: tested: REL-17 WI NR_UE_PC2_n34-Core ; 6/1/22: WID:RP-211980->RP-213034; 22/3/22: Compl:0%->53% ; 20/6/22: FCD:12/09/2022->22/06/2022; Rapporteur: CMCC->Dan SONG, CMCC; Rap eMail: ->songdan@chinamobile.com12/7/22: WID:RP-211980->RP-221760 / WI rapporteur name: Dan SONG, CMCC / WI rapporteur e-mail: songdan@chinamobile.com
- 1673: WI rapporteur name: CMCC
- 1674: ; 29/9/21: 0%->100 / WI rapporteur name: CMCC
- 1675: ; 29/9/21: 0%->100 / WI rapporteur name: CMCC
- 1676: tested: REL-17 WI NR_UE_PC2_n39-Core ; 6/1/22: WID:RP-211981->RP-213035; 22/3/22: Compl:0%->47% ; 20/6/22: Rapporteur: CMCC->Dan SONG, CMCC; Rap eMail: ->songdan@chinamobile.com ...; 23/9/22: WID:RP-211981->RP-222651; 9/12/22: FCD:23/03/2023->01/0...; 6/9/23: FCD:09/09/2023->22/09/2023; Compl:99%->100%; Stat Rep: RP-230282->RP-232243; / WI rapporteur name: Dan SONG, CMCC / WI rapporteur e-mail: songdan@chinamobile.com
- 1677: compare REL-17 WI NR_FR2_FWA_Bn257_Bn258 / WI rapporteur name: SoftBank Corp., KDDI, NTT DOCOMO, Rakuten Mobile, Qualcomm
- 1678: compare REL-17 WI NR_FR2_FWA_Bn257_Bn258 ; 29/9/21: 0%->100 / WI rapporteur name: SoftBank Corp., KDDI, NTT DOCOMO, Rakuten Mobile, Qualcomm
- 1679: compare REL-17 WI NR_FR2_FWA_Bn257_Bn258 ; 6/1/22: 0%->100 / WI rapporteur name: SoftBank Corp., KDDI, NTT DOCOMO, Rakuten Mobile, Qualcomm
- 1680: no Perf. part; compare RAN2 REL-15 WI LTE_UDC-Core ; 2/7/21: WID:RP-210909->RP-211203; 5/4/22: WID:RP-211203->RP-220140 / WI rapporteur name: CATT
- 1681: no Perf. Part; compare RAN2 REL-15 WI LTE_UDC-Core ; ;…; 5/4/22: WID:RP-211203->RP-220140 / WI rapporteur name: CATT
- 1682: 9/9/22: Comp...; 9/12/22: FCD:23/06/2023->01/06/2023; Compl:7%->33%; Stat Rep: ->RP-223139; Rapporteur: CATT->Huiying ZHANG, CATT; Rap eMail: ->zhanghuiying@catt.cn; 17/3/23: Compl:33%->67%; Stat Rep: RP-223139->RP-230395; ;... / WI rapporteur name: Huiying ZHANG, CATT / WI rapporteur e-mail: zhanghuiying@catt.cn
- 1683: ; 1/10/21: 38.868 added;; 6/1/22: WID:RP-210910->RP-213535 ; / WI rapporteur name: Huawei
- 1684: TR 38.8XX; to collect agreements on rules and guidelines of specifying band combinations covering NR CA, NR DC and EN-DC ; 2/7/21: WID:RP-210773->RP-211146; 2/7/21: 38.862 added;13/9/21: Compl:0%->50%13/9/21: CD:Sat 12/03/22->Tue 22/03/2213/9/21: Stat / WI rapporteur name: ZTE

| ID | WBS | Task | Duration | Start | Finish | Complete | Remaining | Total slack | Constraint | Resources | Work | Actual work | Acronym | PCG approved | WI rapporteur name | Release | TSG approved | Impacted TSs and TRs | WI rapporteur e-mail | Status Report |
| --- | --- | --- | --- | --- | --- | --- | --- | --- | --- | --- | --- | --- | --- | --- | --- | --- | --- | --- | --- | --- |
| 1685 | 768 | **Multiple Input Multiple Output (MIMO) Over-the-Air (OTA) requirements for NR UEs** | 909d | 2020-06-22 A | 2023-12-12 A | 100% |  |  |  |  | 11536h | 11536h | NR_MIMO_OTA | 45 | CAICT | Rel-17 | 88 |  |  |  |
| 1686 | 768.1 | Core part: NR_MIMO_OTA | 523d | 2020-06-22 A | 2022-06-22 A | 100% |  |  | finish no earlier than 2022-06-22 | R4 | 4184h | 4184h | NR_MIMO_OTA-Core | 45 | Zhu, Siting; Xing, Jinqiang, CAICT, OPPO | Rel-17 | 88 | 38.151 | zhusiting@caict.ac.cn xingjinqiang@oppo.com | RP-221382 |
| 1687 | 768.2 | Perf. Part: NR_MIMO_OTA | 589d | 2020-06-22 A | 2022-09-22 A | 100% |  |  | finish no earlier than 2022-09-22 | R4 | 4712h | 4712h | NR_MIMO_OTA-Perf | 45 | Zhu, Siting; Xing, Jinqiang, CAICT, OPPO | Rel-17 | 88 |  | zhusiting@caict.ac.cn xingjinqiang@oppo.com | RP-222634 |
| 1688 | 768.3 | UE Conformance - Multiple Input Multiple Output (MIMO) Over-the-Air (OTA) requirements for NR UEs | 330d | 2022-09-08 A | 2023-12-12 A | 100% |  |  | finish no earlier than 2023-12-12 | R5 | 2640h | 2640h | NR_MIMO_OTA-UEConTest | 49 | Istvan Szini, Apple | Rel-17 | 97 | 38.551 | Istvan@apple.com | RP-233312 |
| 1689 | 769 | **Introduction of FR2 FWA (Fixed Wireless Access) UE with maximum TRP (Total Radiated Power) of 23dBm for band n257 and n258** | 1236d | 2020-03-25 A | 2024-12-12 | 56% | 542.8d | 318d |  |  | 8800h | 3032h | NR_FR2_FWA_Bn257_Bn258 | 44 | Softbank | Rel-17 | 87 |  |  |  |
| 1690 | 769.1 | Core part: NR_FR2_FWA_Bn257_Bn258 | 125d | 2020-03-25 A | 2020-09-15 A | 100% |  |  | finish no earlier than 2020-09-15 | R4 | 1000h | 1000h | NR_FR2_FWA_Bn257_Bn258-Core | 44 | Softbank | Rel-17 | 87 |  |  |  |
| 1691 | 769.2 | Perf. Part: NR_FR2_FWA_Bn257_Bn258 | 254d | 2020-03-25 A | 2021-03-15 A | 100% |  |  | finish no earlier than 2021-03-15 | R4 | 2032h | 2032h | NR_FR2_FWA_Bn257_Bn258-Perf | 44 | Softbank | Rel-17 | 87 |  |  |  |
| 1692 | 769.3 | UE Conformance - Introduction of FR2 FWA (Fixed Wireless Access) UE with maximum TRP (Total Radiated Power) of 23dBm for band n257 and n258 | 721d | 2022-03-15 A | 2024-12-12 | 33% | 483.07d | 318d | finish no earlier than 2024-12-12 | R5 | 5768h |  | NR_FR2_FWA_Bn257_Bn258-UEConTest | 48 | Yuxin Hao, Huawei Technologies. Co., Ltd. | Rel-17 | 95 |  | haoyuxin@huawei.com | RP-240279 |
| 1693 | 770 | **Adding channel bandwidth support to existing NR bands** | 524d | 2020-06-22 A | 2022-06-22 A | 100% |  |  |  |  | 4184h | 4184h | NR_bands_R17_BWs | 45 | Ericsson | Rel-17 | 88 |  |  |  |
| 1694 | 770.1 | Core part: NR_bands_R17_BWs | 523d | 2020-06-22 A | 2022-06-22 A | 100% |  |  | finish no earlier than 2022-06-22 | R4 | 4184h | 4184h | NR_bands_R17_BWs-Core | 45 | Dominique Everaere, Ericsson | Rel-17 | 88 |  | dominique.everaere@ericsson.com | RP-221213 |
| 1695 | 771 | **Introduction of channel bandwidths 35MHz and 45MHz for NR FR1** | 262d | 2020-03-19 A | 2021-03-19 A | 100% |  |  |  |  | 4192h | 4192h | NR_FR1_35MHz_45MHz_BW | 45 | Huawei | Rel-17 | 88 |  |  |  |
| 1696 | 771.1 | Core part: NR_FR1_35MHz_45MHz_BW | 262d | 2020-03-19 A | 2021-03-19 A | 100% |  |  | finish no earlier than 2021-03-19 | R4 | 2096h | 2096h | NR_FR1_35MHz_45MHz_BW-Core | 45 | Huawei | Rel-17 | 88 |  |  |  |
| 1697 | 771.2 | Perf. Part: NR_FR1_35MHz_45MHz_BW | 262d | 2020-03-19 A | 2021-03-19 A | 100% |  |  | finish no earlier than 2021-03-19 | R4 | 2096h | 2096h | NR_FR1_35MHz_45MHz_BW-Perf | 45 | Huawei | Rel-17 | 88 |  |  |  |
| 1698 | 772 | **SAR schemes for UE power class 2 (PC2) for NR inter-band Carrier Aggregation and supplemental uplink (SUL) configurations with 2 bands UL** | 657d | 2020-03-19 A | 2022-09-22 A | 100% |  |  |  |  | 10000h | 10000h | NR_SAR_PC2_interB_SUL_2BUL | 45 | China Telecom | Rel-17 | 88 |  |  |  |
| 1699 | 772.1 | Core part: NR_SAR_PC2_interB_SUL_2BUL | 394d | 2020-03-19 A | 2021-09-21 A | 100% |  |  | finish no earlier than 2021-09-21 | R4 | 3152h | 3152h | NR_SAR_PC2_interB_SUL_2BUL-Core | 45 | China Telecom | Rel-17 | 88 |  |  | RP-211830 |
| 1700 | 772.2 | Perf. Part: NR_SAR_PC2_interB_SUL_2BUL | 523d | 2020-03-19 A | 2022-03-21 A | 100% |  |  | finish no earlier than 2022-03-21 | R4 | 4184h | 4184h | NR_SAR_PC2_interB_SUL_2BUL-Perf | 45 | China Telecom | Rel-17 | 88 |  |  | RP-211830 |
| 1701 | 772.3 | UE Conformance - SAR schemes for UE power class 2 (PC2) for NR inter-band Carrier Aggregation and supplemental uplink (SUL) configurations with 2 bands UL | 333d | 2021-06-15 A | 2022-09-22 A | 100% |  |  | finish no earlier than 2022-09-22 | R5 | 2664h | 2664h | NR_SAR_PC2_interB_SUL_2BUL-UEConTest | 47 | Jingzhou Wu, China Telecom | Rel-17 | 92 |  | wujingzhou@chinatelecom.cn | RP-221295 |
| 1702 | 773 | **NR coverage enhancements** | 1304d | 2019-03-07 A | 2024-03-01 A | 100% |  |  |  |  | 13552h | 13552h | NR_cov_enh | 46 | China Telecom | Rel-17 | 90 |  |  |  |
| 1703 | 773.1 | Study on on NR coverage enhancements | 325d | 2019-03-07 A | 2020-06-03 A | 100% |  |  |  | R1 | 2600h | 2600h | FS_NR_cov_enh | 44 | China Telecom | Rel-17 | 86 |  |  |  |
| 1704 | 773.2 | Core part: NR_cov_enh | 325d | 2020-12-14 A | 2022-03-11 A | 100% |  |  | finish no earlier than 2022-03-22 | R1 | 2600h | 2600h | NR_cov_enh-Core | 46 | China Telecom | Rel-17 | 90 |  |  | RP-220563 |
| 1705 | 773.3 | Perf. part: NR_cov_enh | 529d | 2020-12-14 A | 2022-12-21 A | 100% |  |  | finish no earlier than 2022-12-22 | R1 | 4232h | 4232h | NR_cov_enh-Perf | 46 | Jianchi Zhu, China Telecom | Rel-17 | 90 |  | zhujc@chinatelecom.cn | RP-221283 / 1817 |
| 1706 | 773.4 | UE Conformance - NR coverage enhancements | 515d | 2022-03-15 A | 2024-03-01 A | 100% |  |  | finish no earlier than 2024-03-01 | R5 | 4120h | 4120h | NR_cov_enh-UEConTest | 48 | Jingzhou Wu, China Telecom | Rel-17 | 95 |  | wujingzhou@chinatelecom.cn | RP-240340 |
| 1707 | 774 | **Support of reduced capability NR devices** | 1102d | 2019-12-16 A | 2024-03-01 A | 100% |  |  |  |  | 16264.2h | 16264.2h | NR_redcap | 46 | Ericsson | Rel-17 | 90 |  |  |  |
| 1708 | 774.1 | Study on support of reduced capability NR devices | 131d | 2019-12-16 A | 2020-06-15 A | 100% |  |  | finish no earlier than 2020-06-15 | R1 | 1048h | 1048h | FS_NR_redcap | 44 | Ericsson | Rel-17 | 86 |  |  |  |
| 1709 | 774.2 | Core part: NR_redcap | 398d | 2020-12-14 A | 2022-06-22 A | 100% |  |  | finish no earlier than 2022-06-22 | R1 | 3184h | 3184h | NR_redcap-Core | 46 | Johan BERGMAN, Ericsson | Rel-17 | 90 |  | johan.bergman@ericsson.com | RP-221162 |
| 1710 | 774.3 | Perf. part: NR_redcap | 529d | 2020-12-14 A | 2022-12-22 A | 100% |  |  | finish no earlier than 2022-12-22 | R1 | 4232h | 4232h | NR_redcap-Perf | 46 | Johan BERGMAN, Ericsson | Rel-17 | 90 |  | johan.bergman@ericsson.com | RP-221162 |
| 1711 | 774.4 | UE Conformance - Support of reduced capability NR devices | 515d | 2022-03-15 A | 2024-03-01 A | 100% |  |  | finish no earlier than 2024-03-01 | R5 | 4120h | 4120h | NR_redcap_plus_ARCH-UEConTest | 48 | Shi，Yu, China Unicom | Rel-17 | 95 |  | shiyu19@chinaunicom.cn | RP-240050 |
| 1712 | 774.5 | Architecture Enhancement for NR Reduced Capability Devices | 66d | 2021-09-10 A | 2021-12-10 A | 100% |  |  | finish no earlier than 2021-12-12 | S2 | 528h | 528h | ARCH_NR_REDCAP | 47 | Aihua Li, China Mobile | Rel-17 | 93 | 23.501; 23.502 | liaihua@chinamobile.com |  |
| 1713 | 774.6 | CT1 aspects of NR_redcap | 66d | 2021-12-10 A | 2022-03-11 A | 100% |  |  | finish no earlier than 2022-03-12 | C1 | 528h | 528h | ARCH_NR_REDCAP | 48 | Chen Xu, China Mobile | Rel-17 | 94 | 24.501; 23.122; 24.008; 24.368 | chenxu@chinamobile.com |  |
| 1714 | 774.7 | CT3 aspects of NR_redcap | 65.02d | 2021-12-10 A | 2022-03-11 A | 100% |  |  | finish no earlier than 2022-03-11 | C3 | 520.16h | 520.16h | ARCH_NR_REDCAP | 48 | Chen Xu, China Mobile | Rel-17 | 95 | 24.501; 23.122; 24.008; 24.368 | chenxu@chinamobile.com |  |
| 1715 | 774.8 | CT4 aspects of NR_redcap | 66d | 2021-12-10 A | 2022-03-11 A | 100% |  |  | finish no earlier than 2022-03-12 | C4 | 528h | 528h | ARCH_NR_REDCAP | 48 | Chen Xu, China Mobile | Rel-17 | 94 | 29.571; 29.502; 29.540; 29.518; 23.008 | chenxu@chinamobile.com |  |
| 1716 | 774.9 | CT6 aspects of NR_redcap | 66d | 2021-12-10 A | 2022-03-11 A | 100% |  |  | finish no earlier than 2022-03-12 | C6 | 528h | 528h | ARCH_NR_REDCAP | 48 | Chen Xu, China Mobile | Rel-17 | 95 | 29.571; 29.502; 29.540; 29.518; 23.008 | chenxu@chinamobile.com |  |
| 1717 | 774.10 | Charging aspects of Architecture Enhancement for NR Reduced Capability Devices | 131d | 2021-12-10 A | 2022-06-10 A | 100% |  |  | finish no earlier than 2022-06-12 | S5 | 1048h | 1048h | ARCH_NR_REDCAP | 48 | Dong, Jia, China Mobile | Rel-17 | 94 | 32.255; 32.298; 32.291 | dongjia@chinamobile.com |  |

Notes:
- 1685: 25/9/20: WID:RP-201302->RP-201800; 6/1/22: WID:RP-201800->RP-213101
- 1686: 25/9/20: 38.151 added;; 13/9/21: Compl:0%->83%; ; 20/6/22: Rapporteur: CAICT->Zhu, Siting; Xing, Jinqiang, CAICT, OPPO; Rap eMail: ->zhusiting@caict.ac.cn xingjinqiang@oppo.com;
- 1687: ; 13/9/21: Compl:0%->20%; 13/9/21: CD:Wed 15 ; 22/3/22: Compl:20%->35%; ; 6/6/22: Compl:35%->55% 20/6/22: Rapporteur: CAICT->Zhu, Siting; Xing, Jinqiang, CAICT, OPPO; Rap eMail: ->zhusiting@caict.ac.cn xingjinqiang@oppo.com 9/...; 23/9/22: 90%->100; 23/9/22: WID:RP-213101->RP-222348
- 1688: 19/10/22: 38.551 added;; 9/12/22: FCD:10/12/2023->01/12/2023; Compl:0%->5%; Stat Rep: ->RP-223198; Rapporteur: Apple->Istvan Szini, Apple; Rap eMail: ->Istvan@apple.com; 17/3/23: FCD:30/11/2023->12/12/2023; Compl:5%->8%; Stat Rep: RP-223198->RP-2301.....; 8/12/23: Compl:50%->100%; Stat Rep: RP-231969->RP-233312;
- 1689: affects: NR. TR 38.8xx; 28/7/20: WID:RP-200503->RP-201215; 25/9/20: WID:RP-201215->RP-201598; 6/1/21: WID:RP-201598->RP-202565
- 1690: affects: NR. TR 38.8xx; 7/4/21: 0%->100
- 1691: affects: NR. TR 38.8xx; 7/4/21: 0%->100
- 1692: tested: REL-17 WI NR_FR2_FWA_Bn257_Bn258-Core 6/6/22: Compl:0%->5% 6/6/22 ; 20/6/22: Rapporteur: Huawei->Yuxin Hao, Huawei Technologies. Co., Ltd.; Rap eMail: ->haoyuxin@huawei.com; 9/12/22: FCD:23/12/2022->01/12/2023; Stat Rep: RP-221492->RP-223221.....; 14/3/24: FCD:11/12/2024->12/12/2024; Stat Rep: RP-233761->RP-240279;
- 1693: 25/9/20: WID:RP-201294->RP-202062; 6/1/21: WID:RP-202062->RP-202277; 7/4/21: WID:RP-202277->RP-210917; 2/7/21: WID:RP-210917->RP-211599; 29/9/21: WID:RP-211599->RP-212531; 6/1/22: WID:RP-212531->RP-213248; 5/4/22: WID:RP-213248->RP-220160; 12/7/22: WID:RP-220160->RP-221212
- 1694: ; 13/9/21: Compl:0%->50%; 13/9/21: CD:Wed 15/09/21->Tue 22/03/22; ; 22/3/22: Compl:50%->80%; 20/6/22: Rapporteur: Ericsson->Dominique Everaere, Ericsson; Rap eMail: ->dominique.everaere@ericsson.com;
- 1695: 25/9/20: WID:RP-201321->RP-201722; 6/1/21: WID:RP-201722->RP-202607; 7/4/21: WID:RP-202607->RP-210722; 2/7/21: WID:RP-210722->RP-211386
- 1696: 29/9/21: 0%->100
- 1697: 29/9/21: 0%->100
- 1698: 25/9/20: WID:RP-201337->RP-201584; 2/7/21: WID:RP-201584->RP-211494; 29/9/21: WID:RP-211494->RP-212530
- 1699: 25/9/20: WID:RP-201337->RP-201584; 13/9/21: Compl:0%->100%; 13/9/21: CD:Fri 19/03/21->Tue 21/09/21; 13/9/21: WID: RP-211494->RP-201337 RP-201584 RP-211494; ; 29/9/21: 100%->100
- 1700: 7/4/21: 0%->100; 13/9/21: CD:Fri 19/03/21->Mon 21/03/22; 13/9/21: WID: RP-211494->RP-201337 RP-201584 RP-211494; 13/9/21: Stat Rep: ->RP-211830
- 1701: tested: REL-17 WI NR_SAR_PC2_interB_SUL_2BUL-Core ; 13/9/21: Compl:0%->5%; 13/9/21: CD:Tue 15/03/22->Tue 22/03/22; 13/9/ ; 22/3/22: Compl:5%->23% ; 20/6/22: Rapporteur: China Telecom->Jingzhou Wu, China Telecom; Rap eMail: ->wujingzhou@chinateleco...
- 1702: follow-up WI of REL-17 SI FS_NR_cov_enh ; 7/4/21: WID:RP-202928->RP-210855; 2/7/21: WID:RP-210855->RP-211566
- 1703: affects: NR. TR 38.8xx; 28/7/20: WID:RP-193240->RP-200861; 6/1/21: 0%->100
- 1704: follow-up WI of REL-17 SI FS_NR_cov_enh ; 13/9/21: Compl:0%->60%; 13/9/21: CD:Sat 12/03/22->Tue 22/03/22; 13/9/21: Stat Rep: ->RP-211826 ;
- 1705: follow-up WI of REL-17 SI FS_NR_cov_enh ; 13/9/21: CD:Thu 08/09/22->Wed 22/09/21; 13/9/21: Stat Rep: ->RP-211826; 22/3/22: Compl:0%->35% 20/6/22: WG: R4->R1; FCD:12/09/2022->22/09/2022; Compl:35%->60%; Stat Rep: RP-220563->RP-221283 / 1817; Rappor...; 9/1/23: 90%->100
- 1706: tested: REL-17 WI NR_cov_enh-Core ; 6/6/22: Compl:0%->5% ; 6/6/22: CD:15/06/2023->23/ ; 20/6/22: Rapporteur: China Telecom->Jingzhou Wu, China Telecom; Rap eMail: ->wujingzhou@chinatelecom.cn12/7/22: WID:RP-220576->RP-221298 ; ;...; 9/12/22: FCD:23/06...; 2/4/24: WID:RP-221298->RP-240341
- 1707: follow-up WI of REL-17 SI FS_NR_redcap (not yet completed at RAN #90e) ; 7/4/21: WID:RP-202933->RP-210918; 2/7/21: WID:RP-210918->RP-211574; 5/4/22: WID:RP-211574->RP-220966
- 1708: affects: NR. TR 38.8xx; 28/7/20: WID:RP-193238->RP-201386; 25/9/20: WID:RP-201386->RP-201677; 6/1/21: WID:RP-201677->RP-202704; 7/4/21: 0%->100
- 1709: follow-up WI of REL-17 SI FS_NR_redcap (not yet completed at RAN #90e) ; 22/ 20/6/22: Rapporteur: Ericsson->Johan BERGMAN, Ericsson; Rap eMail: ->johan.bergman@ericsson.com;
- 1710: follow-up WI of REL-17 SI FS_NR_redcap ; 22/3/22: Compl:0%->25%; 22/3/22: CD:08/09/2022- 6/6/22: Compl ; 20/6/22: WG: R4->R1; Rapporteur: Ericsson->Johan BERGMAN, Ericsson; Rap eMail: ->johan.bergman@ericsson.com ...; 9/12/22: 75%->100; 9/1/23: 100%...; 9/1/23: 100%->100
- 1711: tested: REL-17 WI NR_redcap-Core and CT1 REL-17 WI ARCH_NR_REDCAP 6/6/22: Compl:0%->13% ; 20/6/22: Rapporteur: China Unicom->Shi，Yu, China Unicom; Rap eMail: ->shiyu19@chinaunicom.cn ...; 23/9/22: WID:RP-222830->RP-222136; 9/12/22: FCD:23/06/2023->...; 2/4/24: WID:RP-232770->RP-240053
- 1712: ; 10/12/21: 0%->100
- 1713: 12/3/22: 0%->98; 12/3/22: FCD:10/06/2022->3/22; 4/6/22: 98%->100
- 1714: 12/3/22: 0%->98; 12/3/22: FCD:10/06/2022->3/22; 12/3/22: WID:CP-213081->CP-220304; 12/3/22: 0%->100; 4/6/22: WID:CP-220304->CP-221265
- 1715: 12/3/22: 20%->98; 12/3/22: FCD:10/06/2022->3/22; 4/6/22: 98%->100
- 1716: 12/3/22: 20%->98; 12/3/22: FCD:10/06/2022->3/22; 12/3/22: 0%->100; 4/6/22: 100%->
- 1717: ; 12/3/22: 0%->35; 4/6/22: 35%->100

| ID | WBS | Task | Duration | Start | Finish | Complete | Remaining | Total slack | Constraint | Resources | Work | Actual work | Acronym | PCG approved | WI rapporteur name | Release | TSG approved | WI rapporteur e-mail | Status Report | Impacted TSs and TRs |
| --- | --- | --- | --- | --- | --- | --- | --- | --- | --- | --- | --- | --- | --- | --- | --- | --- | --- | --- | --- | --- |
| 1718 | 775 | **Additional NR bands for UL-MIMO power class 3 (PC3) in Rel-17** | 648d | 2020-12-14 A | 2023-06-06 A | 100% |  |  |  |  | 9464h | 9464h | NR_bands_UL_MIMO_PC3_R17 | 46 | Huawei | Rel-17 | 90 |  |  |  |
| 1719 | 775.1 | Core part: NR_bands_UL_MIMO_PC3_R17 | 398d | 2020-12-14 A | 2022-06-22 A | 100% |  |  | finish no earlier than 2022-06-22 | R4 | 3184h | 3184h | NR_bands_UL_MIMO_PC3_R17-Core | 46 | Liu Ye, Huawei | Rel-17 | 90 | leo.liuye@huawei.com | RP-221517 |  |
| 1720 | 775.2 | Perf. part: NR_bands_UL_MIMO_PC3_R17 | 398d | 2020-12-14 A | 2022-06-22 A | 100% |  |  | finish no earlier than 2022-06-22 | R4 | 3184h | 3184h | NR_bands_UL_MIMO_PC3_R17-Perf | 46 | Liu Ye, Huawei | Rel-17 | 90 | leo.liuye@huawei.com | RP-221517 |  |
| 1721 | 775.3 | UE Conformance - Additional NR bands for UL-MIMO in Rel-17 | 387d | 2021-12-13 A | 2023-06-06 A | 100% |  |  | finish no earlier than 2023-06-06 | R5 | 3096h | 3096h | NR_bands_UL_MIMO_PC3_R17-UEConTest | 48 | Yuxin Hao, Huawei Technologies. Co., Ltd. | Rel-17 | 94 | haoyuxin@huawei.com | RP-230431 |  |
| 1722 | 776 | Introduction of bandwidth combination set 4 (BCS4) for NR | 860d | 2019-03-07 A | 2022-06-22 A | 100% |  |  | finish no earlier than 2022-06-22 | R4 | 6880h | 6880h | NR_BCS4-Core | 46 | Per Lindell, Ericsson | Rel-17 | 90 | per.lindell@ericsson.com | RP-221317 |  |
| 1723 | 777 | **Downlink interruption for NR and EN-DC band combinations to conduct dynamic Tx Switching in Uplink** | 842d | 2020-12-14 A | 2024-03-01 A | 100% |  |  |  |  | 7760h | 7760h | DL_intrpt_combos_TxSW_R17 | 46 | China Telecom | Rel-17 | 90 |  |  | 37.867 |
| 1724 | 777.1 | Core part: DL_intrpt_combos_TxSW_R17 | 325d | 2020-12-14 A | 2022-03-11 A | 100% |  |  | finish no earlier than 2022-03-22 | R4 | 2600h | 2600h | DL_intrpt_combos_TxSW_R17-Core | 46 | China Telecom | Rel-17 | 90 |  | RP-220570 |  |
| 1725 | 777.2 | Perf. part: DL_intrpt_combos_TxSW_R17 | 325d | 2020-12-14 A | 2022-03-11 A | 100% |  |  | finish no earlier than 2022-03-22 | R4 | 2600h | 2600h | DL_intrpt_combos_TxSW_R17-Perf | 46 | China Telecom | Rel-17 | 90 |  | RP-220570 |  |
| 1726 | 777.3 | UE Conformance - Downlink interruption for NR and EN-DC band combinations to conduct dynamic Tx Switching in Uplink | 320d | 2022-12-13 A | 2024-03-01 A | 100% |  |  | finish no earlier than 2024-03-01 | R5 | 2560h | 2560h | DL_intrpt_combos_TxSW_R17-UEConTest | 50 | Jingzhou Wu, China Telecom | Rel-17 | 98 | wujingzhou@chinatelecom.cn | RP-240342 |  |
| 1727 | 778 | **High-power UE (power class 1.5) operation in NR bands n77 and n78** | 515d | 2020-12-14 A | 2022-12-01 A | 100% |  |  |  |  | 4136h | 4136h | HPUE_PC1_5_n77_n78 | 46 | Qualcomm | Rel-17 | 90 |  |  |  |
| 1728 | 778.1 | Core part: HPUE_PC1_5_n77_n78 | 202d | 2020-12-14 A | 2021-09-21 A | 100% |  |  | finish no earlier than 2021-09-21 | R4 | 1616h | 1616h | HPUE_PC1_5_n77_n78-Core | 46 | Qualcomm | Rel-17 | 90 |  | RP-212049 |  |
| 1729 | 778.2 | UE Conformance - High-power UE (power class 1.5) operation in NR bands n77 and n78 | 315d | 2021-09-17 A | 2022-12-01 A | 100% |  |  | finish no earlier than 2022-12-01 | R5 | 2520h | 2520h | HPUE_PC1_5_n77_n78-UEConTest | 47 | Jinwen MA, Tuomo Saynajakangas, Verizon, Nokia | Rel-17 | 93 | jinwen.ma@verizonwireless.com, tuomo.saynajakangas@nokia.com | RP-223280 |  |
| 1730 | 779 | **NR repeaters** | 529d | 2020-12-14 A | 2022-12-21 A | 100% |  |  |  |  | 5296h | 5296h | NR_repeaters | 46 | Qualcomm | Rel-17 | 90 |  |  |  |
| 1731 | 779.1 | Core part: HPUE_PC1_5_n77_n78 | 332d | 2020-12-14 A | 2022-03-22 A | 100% |  |  | finish no earlier than 2022-03-22 | R4 | 2656h | 2656h | NR_repeaters-Core | 46 | Valentin Gheorghiu | Rel-17 | 90 | vgheorgh@qti.qualcomm.com | RP-221566 | 38.114; 38.106 |
| 1732 | 779.2 | Perf. part: NR repeaters | 330d | 2021-09-17 A | 2022-12-21 A | 100% |  |  | finish no earlier than 2022-12-22 | R4 | 2640h | 2640h | NR_repeaters-Perf | 47 | Valentin Gheorghiu | Rel-17 | 93 | vgheorgh@qti.qualcomm.com | RP-221566 | 38.115-2; 38.115-1 |
| 1733 | 780 | **Increasing UE power high limit for CA and DC** | 528d | 2021-09-17 A | 2023-09-22 | 99% | 0d | 0d |  | R4 | 7448h | 4824h | Power_Limit_CA_DC | 47 | Qualcomm | Rel-17 | 93 |  |  |  |
| 1734 | 780.1 | Core part: Increasing UE power high limit for CA and DC | 199d | 2021-09-17 A | 2022-06-22 A | 100% |  |  | finish no earlier than 2022-06-22 | R4 | 1592h | 1592h | Power_Limit_CA_DC-Core | 47 | Gene Fong, Qualcomm Incorporated | Rel-17 | 93 | gfong@qti.qualcomm.com | RP-221588 |  |
| 1735 | 780.2 | UE Conformance - Increasing UE power high limit for CA and DC | 205d | 2022-12-13 A | 2023-09-22 A | 100% |  |  | finish no earlier than 2023-09-22 | R5 | 1640h | 1640h | Power_Limit_CA_DC-UEConTest | 50 | Kevin Wang / Jingzhou wu, Qualcomm / China Telecom | Rel-17 | 98 | kevinw@qti.qualcomm.com /wujingzhou@chinatelecom.cn | RP-232018 |  |
| 1736 | 781 | **Introduction of upper 700MHz A block E-UTRA band for the US** | 316d | 2021-09-17 A | 2022-12-01 | 99% | 0d | 0d |  | R4 | 5512h | 4016h | LTE_upper_700MHz_A | 47 | Puloli | Rel-17 | 93 |  |  |  |
| 1737 | 781.1 | Core part: Introduction of upper 700MHz A block E-UTRA band for the US | 126d | 2021-09-17 A | 2022-03-11 A | 100% |  |  | finish no earlier than 2022-03-15 | R4 | 1008h | 1008h | LTE_upper_700MHz_A-Core | 47 | Puloli | Rel-17 | 93 |  | RP- 220404 | 36.779 |
| 1738 | 781.2 | Perf. part: Introduction of upper 700MHz A block E-UTRA band for the US | 126d | 2021-09-17 A | 2022-03-11 A | 100% |  |  | finish no earlier than 2022-03-15 | R4 | 1008h | 1008h | LTE_upper_700MHz_A-Perf | 47 | Puloli | Rel-17 | 93 |  | RP- 220404 |  |
| 1739 | 781.3 | UE Conformance - Introduction of upper 700MHz A block E-UTRA band for the US (band 103) | 122d | 2022-06-15 A | 2022-12-01 A | 100% |  |  | finish no earlier than 2022-12-01 | R5 | 976h | 976h | LTE_upper_700MHz_A-UEConTest | 49 | Heng Pan, Puloli | Rel-17 | 96 | heng.pan@puloli.com | RP-222802 |  |
| 1740 | 782 | **High power UE (power class 2) for one NR FDD band** | 316d | 2021-09-17 A | 2022-12-01 | 99% | 0d | 0d |  | R4 | 5512h | 4016h | NR_PC2_UE_FDD | 47 | China Unicom | Rel-17 | 93 |  |  |  |
| 1741 | 782.1 | Core part: High power UE (power class 2) for one NR FDD band | 126d | 2021-09-17 A | 2022-03-11 A | 100% |  |  | finish no earlier than 2022-03-15 | R4 | 1008h | 1008h | NR_PC2_UE_FDD-Core | 47 | China Unicom | Rel-17 | 93 |  | RP-220381 |  |
| 1742 | 782.2 | Perf. part: High power UE (power class 2) for one NR FDD band | 126d | 2021-09-17 A | 2022-03-11 A | 100% |  |  | finish no earlier than 2022-03-15 | R4 | 1008h | 1008h | NR_PC2_UE_FDD-Perf | 47 | China Unicom | Rel-17 | 93 |  | RP-220381 |  |
| 1743 | 782.3 | UE Conformance - High power UE (power class 2) for one NR FDD band | 122d | 2022-06-15 A | 2022-12-01 A | 100% |  |  | finish no earlier than 2022-12-01 | R5 | 976h | 976h | NR_PC2_UE_FDD-UEConTest | 49 | Shi，Yu, China Unicom | Rel-17 | 96 | shiyu19@chinaunicom.cn | RP-222808 |  |

Notes:
- 1718: basket WI ; 7/4/21: WID:RP-202819->RP-210557; 2/7/21: WID:RP-210557->RP-211380; 29/9/21: WID:RP-211380->RP-212184; 6/1/22: WID:RP-212184->RP-213137; 5/4/22: WID:RP-213137->RP-220704; 12/7/22: WID:RP-220704->RP-221518
- 1719: basket WI ; 13/9/21: Compl:0%->70%; 20/6/22: WID: ->RP-213136; Rapporteur: Huawei->Liu Ye, Huawei; Rap eMail: ->leo.liuye@huawei.com;
- 1720: basket WI ; 13/9/21: CD:Sun 12/06/22->Tue 22/03/22; ; 20/6/22: WID: ->RP-213136; Rapporteur: Huawei->Liu Ye, Huawei; Rap eMail: ->leo.liuye@huawei.com;
- 1721: tested: REL-17 WI NR_bands_UL_MIMO_PC3_R17; 22/3/22: Compl:0%->8%; 22/3/22: Stat Rep: ->RP-220419; 5/4/22: WID:RP-213227->RP-220745 ; 6/6/22: CD:12/09/2022->22 ; 20/6/22: Rapporteur: Huawei->Yuxin Hao, Huawei Technologies. Co., Ltd.; Rap eMail: ->haoyu...; ; ; ; ; ; ; ; ; ; ; ; ; ; ; ; ; ; ; ; ; ; ; ; ; ; ; ; ; ; ; ; ; ; ; ; ; ; ; ; ; ; ; ; ; ; ; ; ; ; ; ; ; ; ; ; ; ; ; ; ; ; ; ; ; ; 7/6/23: Compl:73%->100%
- 1722: no Perf. part ; 20/6/22: FCD:03/06/2020->22/06/2022; Compl:0%->100%; Stat Rep: ->RP-221317; Rapporteur: Ericsson->Per Lindell, Ericsson; Rap eMail: ->per.lindell@ericsson.com;
- 1723: basket WI; TR 37.8xx ; 7/4/21: WID:RP-202885->RP-210478; 2/7/21: 37.867 added;
- 1724: basket WI; TR 37.8xx ; 13/9/21: Compl:0%->60%; 13/9/21: CD:Sat 12/03/22->Tue 22/03/22; 13/9/21: WID: RP-210478->RP-202885 RP-210478 ; ;
- 1725: basket WI ; 13/9/21: CD:Sat 12/03/22->Tue 22/03/22; 13/9/21: WID: RP-210478->RP-202885 RP-210478; 13/9/21: Stat Rep: ->RP-211833 ;
- 1726: 17/3/23: FCD:12/12/2023->06/06/2023; Compl:0%->5%; Stat Rep: ->RP-230318; Rapporteur: China Telecom->Jingzhou Wu, China Telecom; Rap eMail: ->wujingzhou@chinatelecom.cn; 31/3/23: FCD:06/06/2023->12/12/2023; Stat Rep: RP-230318->RP-230715; ...; 6/9/23:...; 2/4/24: WID:RP-222948->RP-240785
- 1727: no Perf. part
- 1728: no Perf. part ; 13/9/21: Compl:0%->100% ; 29/9/21: 100%->100
- 1729: tested: REL-17 WI HPUE_PC1_5_n77_n78-Core ; 22/3/22: Compl:0%->50%; ; 6/6/22: Compl:50%->61%20/6/22: Rapporteur: Verizon->Jinwen MA, Tuomo Saynajakangas, Verizon, Nokia; Rap eMail: ->jinwen.ma@verizonwireless.com, tuomo.saynajakangas@nokia.com; ...;...; 9/1/23: 100%->100
- 1730: no Perf. part ; 7/4/21: WID:RP-202927->RP-210818; 29/9/21: WID:RP-210818->RP-212129; 6/1/22: WID:RP-212129->RP-213514
- 1731: no Perf. part ; 2/7/21: 38.114 added;; 2/7/21: 38.106 added;; 20/6/22: FCD:12/12/2021->22/03/2023; Compl:0%->100%; WID: RP-213514->RP-212129; Stat Rep: ->RP-221566; Rapporteur: Qualcomm->Valentin Gheorghiu; Rap eMail: ->vgheorgh@qti.qualcomm.com;
- 1732: Core part (UID=900170) started in Dec.20 while Perf. Part (UID=930250) started in 17/09/21 via revised WID RP-212129; TS 38.1??-1, TS 38.1??-2 ; 7/1/22: 38.115-2 and 38.115-1 added;; 20/6/22: FCD:17/09/2022->22/09/2022; Compl:0%->30%; WID: RP-213514->R...; 9/1/23: 80%->100
- 1733: no Perf. part ; 12/7/22: WID:RP-212622->RP-221302
- 1734: no Perf. Part ; 22/3/22: Compl:0%->75%; … 20/6/22: WID: RP-212622->RP-221302; Stat Rep: RP-220514->RP-221588; Rapporteur: Qualcomm->Gene Fong, Qualcomm Incorporated; Rap eMail: ->gfong@qti.qualcomm.com;
- 1735: 17/3/23: FCD:09/09/2023->08/09/2023; Compl:0%->52%; Stat Rep: ->RP-230101; Rapporteur: Qualcomm->Kevin Wang / Jingzhou wu, Qualcomm / China Telecom; Rap eMail: ->kevinw@qti.qualcomm.com /wujingzhou@chinatelecom.cn; ...; 6/9/23: FCD:09/09/2023->22/09/2023; Compl:85%->100%; Stat Rep: RP-230101->RP-232018;
- 1736: specs in [ ]; TR 36.8xx ; 6/1/22: WID:RP-212618->RP-212917
- 1737: specs in [ ]; TR 36.8xx ; 7/1/22: 36.779 added ;
- 1738: specs in [ ] ;
- 1739: 9/9/22: Comp...; 9/12/22: FCD:22/12/2022->01/12/2022; Compl:72%->100%; Stat Rep: ->RP-222802; Rapporteur: Puloli->Heng Pan, Puloli; Rap eMail: ->heng.pan@puloli.com; 9/1/23: 100%->100
- 1740: follow-up WI of SI FS_NR_PC2_UE_FDD; for NR bands n1 and n3
- 1741: follow-up WI of SI FS_NR_PC2_UE_FDD; for NR bands n1 and n3 ;
- 1742: follow-up WI of SI FS_NR_PC2_UE_FDD ;
- 1743: 9/9/22: Comp...; 9/12/22: FCD:23/12/2022->01/12/2022; Compl:67%->100%; WID: RP-221158->RP-222809; Stat Rep: ->RP-222808; Rapporteur: ChinaUnicom->Shi，Yu, China Unicom; Rap eMail: ->shiyu19@chinaunicom.cn; 9/1/23: 100%->100

| ID | WBS | Task | Type | Duration | Start | Finish | Complete | Constraint | Resources | Work | Actual work | Impacted TSs and TRs | Release | Acronym | PCG approved | WI rapporteur name | TSG approved | WI rapporteur e-mail | Status Report | TSG stopped |
| --- | --- | --- | --- | --- | --- | --- | --- | --- | --- | --- | --- | --- | --- | --- | --- | --- | --- | --- | --- | --- |
| 1744 | 783 | **Rel-17 NR Carrier Aggregation** |  | 0d | 2016-06-09 A | 2016-06-09 A | 100% |  |  |  |  | 26.234; 26.247 | Rel-17 |  |  |  |  |  |  |  |
| 1745 | 783.1 | Rel-17 NR intra band Carrier Aggregation (itrabCA) | milestone, manual | 0d | 2016-06-09 A | 2016-06-09 A | 100% |  |  |  |  | 26.234; 26.247 | Rel-17 |  |  |  |  |  |  |  |
| 1746 | 784 | **NR itrabCA for xCC DL/yCC UL including contiguous and non-contiguous spectrum (x>=y)** |  | 1577d | 2016-06-09 A | 2022-06-22 A | 100% |  |  | 8368h | 8368h |  | Rel-17 | NR_CA_R17_Intra | 45 | Ericsson | 88 |  |  |  |
| 1747 | 784.1 | Core part: NR_CA_R17_Intra |  | 523d | 2020-06-22 A | 2022-06-22 A | 100% | finish no earlier than 2022-06-22 | R4 | 4184h | 4184h |  | Rel-17 | NR_CA_R17_Intra-Core | 45 | Per Lindell, Ericsson | 88 | per.lindell@ericsson.com | RP-221314 |  |
| 1748 | 784.2 | Perf. Part: NR_CA_R17_Intra |  | 523d | 2020-06-22 A | 2022-06-22 A | 100% | finish no earlier than 2022-06-22 | R4 | 4184h | 4184h |  | Rel-17 | NR_CA_R17_Intra-Perf | 45 | Per Lindell, Ericsson | 88 | per.lindell@ericsson.com | RP-221314 |  |
| 1749 | 784.3 | Rel-17 NR inter band Carrier Aggregation (iterbCA) | milestone, manual | 0d | 2016-06-09 A | 2016-06-09 A | 100% |  |  |  |  | 26.234; 26.247 | Rel-17 |  |  |  |  |  |  |  |
| 1750 | 785 | **High power UE for NR TDD intra-band Carrier Aggregation in frequency range FR1** |  | 357d | 2021-02-10 A | 2022-06-22 A | 100% |  |  | 5632h | 5632h |  | Rel-17 | NR_intra_HPUE_R17 | 46 | Huawei | 90 |  |  |  |
| 1751 | 785.1 | Core part: NR_intra_HPUE_R17 |  | 356d | 2021-02-10 A | 2022-06-22 A | 100% | finish no earlier than 2022-06-22 | R4 | 2848h | 2848h |  | Rel-17 | NR_intra_HPUE_R17-Core | 46 | Lingyu Kong, Huawei, HiSilicon | 90 | konglingyu4@hisilicon.com | RP-221513 / 1773 |  |
| 1752 | 785.2 | Stopped - Perf. Part: NR_intra_HPUE_R17 |  | 348d | 2021-02-10 A | 2022-06-10 A | 100% | finish no earlier than 2022-06-12 | R4 | 2784h | 2784h |  | Rel-17 | NR_intra_HPUE_R17-Perf | 46 | Huawei | 90 |  | RP-220696 | 96 |
| 1753 | 786 | **NR iterbCA/Dual Connectivity for 2 bands DL with x bands UL (x=1,2)** |  | 524d | 2020-06-22 A | 2022-06-22 A | 100% |  |  | 8368h | 8368h |  | Rel-17 | NR_CADC_R17_2BDL_xBUL | 45 | ZTE | 88 |  |  |  |
| 1754 | 786.1 | Core part: NR_CADC_R17_2BDL_xBUL |  | 523d | 2020-06-22 A | 2022-06-22 A | 100% | finish no earlier than 2022-06-22 | R4 | 4184h | 4184h |  | Rel-17 | NR_CADC_R17_2BDL_xBUL-Core | 45 | Aijun Cao, ZTE | 88 | cao.aijun@zte.com.cn | RP-221251 |  |
| 1755 | 786.2 | Perf. part: NR_CADC_R17_2BDL_xBUL |  | 523d | 2020-06-22 A | 2022-06-22 A | 100% | finish no earlier than 2022-06-22 | R4 | 4184h | 4184h |  | Rel-17 | NR_CADC_R17_2BDL_xBUL-Perf | 45 | Aijun Cao, ZTE | 88 | cao.aijun@zte.com.cn | RP-221251 |  |
| 1756 | 787 | **NR iterbCA for 3 bands DL with 1 band UL** |  | 524d | 2020-06-22 A | 2022-06-22 A | 100% |  |  | 8368h | 8368h |  | Rel-17 | NR_CA_R17_3BDL_1BUL | 45 | CATT | 88 |  |  |  |
| 1757 | 787.1 | Core part: NR_CA_R17_3BDL_1BUL |  | 523d | 2020-06-22 A | 2022-06-22 A | 100% | finish no earlier than 2022-06-22 | R4 | 4184h | 4184h |  | Rel-17 | NR_CA_R17_3BDL_1BUL-Core | 45 | Yuexia Song, CATT | 88 | songyuexia@catt.cn | RP-221462 |  |
| 1758 | 787.2 | Perf. part: NR_CA_R17_3BDL_1BUL |  | 523d | 2020-06-22 A | 2022-06-22 A | 100% | finish no earlier than 2022-06-22 | R4 | 4184h | 4184h |  | Rel-17 | NR_CA_R17_3BDL_1BUL-Perf | 45 | Yuexia Song, CATT | 88 | songyuexia@catt.cn | RP-221462 |  |
| 1759 | 788 | **NR iterbCA/Dual Connectivity for 3 bands DL with 2 bands UL** |  | 524d | 2020-06-22 A | 2022-06-22 A | 100% |  |  | 8368h | 8368h |  | Rel-17 | NR_CADC_R17_3BDL_2BUL | 45 | ZTE | 88 |  |  |  |
| 1760 | 788.1 | Core part: NR_CADC_R17_3BDL_2BUL |  | 523d | 2020-06-22 A | 2022-06-22 A | 100% | finish no earlier than 2022-06-22 | R4 | 4184h | 4184h |  | Rel-17 | NR_CADC_R17_3BDL_2BUL-Core | 45 | Aijun Cao, ZTE | 88 | cao.aijun@zte.com.cn | RP-221254 |  |
| 1761 | 788.2 | Perf. part: NR_CADC_R17_3BDL_2BUL |  | 523d | 2020-06-22 A | 2022-06-22 A | 100% | finish no earlier than 2022-06-22 | R4 | 4184h | 4184h |  | Rel-17 | NR_CADC_R17_3BDL_2BUL-Perf | 45 | Aijun Cao, ZTE | 88 | cao.aijun@zte.com.cn | RP-221254 |  |
| 1762 | 789 | **NR iterbCA for 4 bands DL with 1 band UL** |  | 524d | 2020-06-22 A | 2022-06-22 A | 100% |  |  | 8368h | 8368h |  | Rel-17 | NR_CA_R17_4BDL_1BUL | 45 | Ericsson | 88 |  |  |  |
| 1763 | 789.1 | Core part: NR_CA_R17_4BDL_1BUL |  | 523d | 2020-06-22 A | 2022-06-22 A | 100% | finish no earlier than 2022-06-22 | R4 | 4184h | 4184h |  | Rel-17 | NR_CA_R17_4BDL_1BUL-Core | 45 | Per Lindell, Ericsson | 88 | per.lindell@ericsson.com | RP-221316 |  |
| 1764 | 789.2 | Perf. part: NR_CA_R17_4BDL_1BUL |  | 523d | 2020-06-22 A | 2022-06-22 A | 100% | finish no earlier than 2022-06-22 | R4 | 4184h | 4184h |  | Rel-17 | NR_CA_R17_4BDL_1BUL-Perf | 45 | Per Lindell, Ericsson | 88 | per.lindell@ericsson.com | RP-221316 |  |
| 1765 | 790 | **NR iterbCA/Dual connectivity for DL 4 bands and 2UL bands** |  | 524d | 2020-06-22 A | 2022-06-22 A | 100% |  |  | 8368h | 8368h |  | Rel-17 | NR_CADC_R17_4BDL_2BUL | 45 | Samsung | 88 |  |  |  |
| 1766 | 790.1 | Core part: NR_CADC_R17_4BDL_2BUL |  | 523d | 2020-06-22 A | 2022-06-22 A | 100% | finish no earlier than 2022-06-22 | R4 | 4184h | 4184h |  | Rel-17 | NR_CADC_R17_4BDL_2BUL-Core | 45 | Yue Wu, Samsung | 88 | yue.wu@samsung.com | RP-221397 |  |
| 1767 | 790.2 | Perf. part: NR_CADC_R17_4BDL_2BUL |  | 523d | 2020-06-22 A | 2022-06-22 A | 100% | finish no earlier than 2022-06-22 | R4 | 4184h | 4184h |  | Rel-17 | NR_CADC_R17_4BDL_2BUL-Perf | 45 | Yue Wu, Samsung | 88 | yue.wu@samsung.com | RP-221397 |  |

Notes:
- 1746: 25/9/20: WID:RP-200663->RP-201571; 6/1/21: WID:RP-201571->RP-202187; 7/4/21: WID:RP-202187->RP-210210; 2/7/21: WID:RP-210210->RP-211585; 29/9/21: WID:RP-211585->RP-211757; 6/1/22: WID:RP-211757->RP-212900; 5/4/22: WID:RP-212900->RP-220825; 12/7/22: WID:RP-220825->RP-221319
- 1747: 13/9/21: Compl:0%->24%13/9/21: CD:Wed 15/09/21->Tue 22/03/2213/9/21: Stat Rep: ->RP-211752 ; 20/6/22: Rapporteur: Ericsson->Per Lindell, Ericsson; Rap eMail: ->per.lindell@ericsson.com;
- 1748: 13/9/21: Compl:0%->24%13/9/21: CD:Wed 15/09/21->Tue 22/03/2213/9/21: Stat Rep: ->RP-211752 ; 20/6/22: Rapporteur: Ericsson->Per Lindell, Ericsson; Rap eMail: ->per.lindell@ericsson.com;
- 1750: 7/4/21: WID:RP-202818->RP-210555; 29/9/21: WID:RP-210555->RP-212180; 6/1/22: WID:RP-212180->RP-213133; 5/4/22: WID:RP-213133->RP-220930; 12/7/22: WID:RP-220930->RP-221774
- 1751: ; 13/9/21: Compl:0%->5% ; 22/3/22: Compl:5%->10%; 22/3/22: CD:22/03/2022->10/06/2022 ; 20/6/22: Stat Rep: RP-221513->RP-221513 / 1773; Rapporteur: Huawei->Lingyu Kong, Huawei, HiSilicon; Rap eMail: ->konglingyu4@hisilicon.com;
- 1752: ; 13/9/21: CD:Thu 09/12/21->Wed 22/06/22; ; 22/3/22: CD:22/06/2022->12/06/2022; 22/3/22: WID: RP-213133->RP-213132; 22/3/22: Stat Rep: RP-212179->RP-220696. 12/7/22: stopped at 0%. 0%->100
- 1753: 25/9/20: WID:RP-200672->RP-201539; 6/1/21: WID:RP-201539->RP-202199; 7/4/21: WID:RP-202199->RP-210495; 2/7/21: WID:RP-210495->RP-211058; 29/9/21: WID:RP-211058->RP-212511; 6/1/22: WID:RP-212511->RP-212887; 5/4/22: WID:RP-212887->RP-220144; 12/7/22: WID:RP-220144->RP-221250
- 1754: ; 20/6/22: Rapporteur: ZTE->Aijun Cao, ZTE; Rap eMail: ->cao.aijun@zte.com.cn;
- 1755: ; 20/6/22: Rapporteur: ZTE->Aijun Cao, ZTE; Rap eMail: ->cao.aijun@zte.com.cn;
- 1756: 25/9/20: WID:RP-200922->RP-201787; 6/1/21: WID:RP-201787->RP-202720; 7/4/21: WID:RP-202720->RP-210901; 2/7/21: WID:RP-210901->RP-211215; 29/9/21: WID:RP-211215->RP-212239; 6/1/22: WID:RP-212239->RP-213299; 5/4/22: WID:RP-213299->RP-220738; 12/7/22: WID:RP-220738->RP-221772
- 1757: ; 22/3/22: Compl:0%->95%; 20/6/22: Rapporteur: CATT->Yuexia Song, CATT; Rap eMail: ->songyuexia@catt.cn;
- 1758: ; 22/3/22: CD:15/09/2021->12/06/2022; 22/3/22: Stat Rep: ->RP-220737 ; 20/6/22: Rapporteur: CATT->Yuexia Song, CATT; Rap eMail: ->songyuexia@catt.cn;
- 1759: 25/9/20: WID:RP-201374->RP-201541; 6/1/21: WID:RP-201541->RP-202201; 7/4/21: WID:RP-202201->RP-210497; 2/7/21: WID:RP-210497->RP-211060; 29/9/21: WID:RP-211060->RP-212512; 6/1/22: WID:RP-212512->RP-212889; 5/4/22: WID:RP-212889->RP-220146; 12/7/22: WID:RP-220146->RP-221253
- 1760: ; 20/6/22: Rapporteur: ZTE->Aijun Cao, ZTE; Rap eMail: ->cao.aijun@zte.com.cn;
- 1761: ; 20/6/22: Rapporteur: ZTE->Aijun Cao, ZTE; Rap eMail: ->cao.aijun@zte.com.cn;
- 1762: 25/9/20: WID:RP-200665->RP-201573; 6/1/21: WID:RP-201573->RP-202189; 7/4/21: WID:RP-202189->RP-210760; 2/7/21: WID:RP-210760->RP-211171; 29/9/21: WID:RP-211171->RP-211759; 6/1/22: WID:RP-211759->RP-212902; 5/4/22: WID:RP-212902->RP-220827; 12/7/22: WID:RP-220827->RP-221321
- 1763: 13/9/21: Compl:0%->45%13/9/21: CD:Wed 15/09/21->Tue 22/03/2213/9/21: Stat Rep: ->RP-211754 ; 20/6/22: Rapporteur: Ericsson->Per Lindell, Ericsson; Rap eMail: ->per.lindell@ericsson.com;
- 1764: 13/9/21: Compl:0%->45%13/9/21: CD:Wed 15/09/21->Tue 22/03/2213/9/21: Stat Rep: ->RP-211754 ; 20/6/22: Rapporteur: Ericsson->Per Lindell, Ericsson; Rap eMail: ->per.lindell@ericsson.com;
- 1765: 25/9/20: WID:RP-200869->RP-201640; 6/1/21: WID:RP-201640->RP-202544; 7/4/21: WID:RP-202544->RP-210802; 2/7/21: WID:RP-210802->RP-211194; 29/9/21: WID:RP-211194->RP-212110; 6/1/22: WID:RP-212110->RP-213111; 5/4/22: WID:RP-213111->RP-220676; 12/7/22: WID:RP-220676->RP-221396
- 1766: 20/6/22: FCD:15/09/2021->22/06/2022; Compl:0%->100%; Stat Rep: ->RP-221397; Rapporteur: Samsung->Yue Wu, Samsung; Rap eMail: ->yue.wu@samsung.com;
- 1767: ; 13/9/21: Compl:0%->70%; ; 22/3/22: Compl:70%->90%; 20/6/22: Rapporteur: Samsung->Yue Wu, Samsung; Rap eMail: ->yue.wu@samsung.com;

| ID | WBS | Task | Type | Duration | Start | Finish | Complete | Remaining | Actual finish | Total slack | Constraint | Resources | Work | Actual work | Acronym | PCG approved | WI rapporteur name | Release | TSG approved | WI rapporteur e-mail | Status Report | Impacted TSs and TRs | TSG stopped |
| --- | --- | --- | --- | --- | --- | --- | --- | --- | --- | --- | --- | --- | --- | --- | --- | --- | --- | --- | --- | --- | --- | --- | --- |
| 1768 | 791 | **NR iterbCA for 5 bands DL with x bands UL (x=1, 2)** |  | 524d | 2020-06-22 A | 2022-06-22 A | 100% |  |  |  |  |  | 8368h | 8368h | NR_CADC_R17_5BDL_xBUL | 45 | Huawei | Rel-17 | 88 |  |  |  |  |
| 1769 | 791.1 | Core part: NR_CADC_R17_5BDL_xBUL |  | 523d | 2020-06-22 A | 2022-06-22 A | 100% |  |  |  | finish no earlier than 2022-06-22 | R4 | 4184h | 4184h | NR_CADC_R17_5BDL_xBUL-Core | 45 | Zhang, Peng, Huawei | Rel-17 | 88 | zhangpeng169@huawei.com | RP-221509 |  |  |
| 1770 | 791.2 | Perf. part: NR_CADC_R17_5BDL_xBUL |  | 523d | 2020-06-22 A | 2022-06-22 A | 100% |  |  |  | finish no earlier than 2022-06-22 | R4 | 4184h | 4184h | NR_CADC_R17_5BDL_xBUL-Perf | 45 | Zhang, Peng, Huawei | Rel-17 | 88 | zhangpeng169@huawei.com | RP-221509 |  |  |
| 1771 | 792 | **Rel-17 High power UE for NR inter-band Carrier Aggregation with 2 bands downlink and x bands uplink (x=1,2)** |  | 846d | 2020-09-17 A | 2023-12-12 A | 100% |  |  |  |  |  | 12584h | 12584h | NR_PC2_CA_R17_2BDL_2BUL | 45 | China Telecom | Rel-17 | 89 |  |  | 38.841 |  |
| 1772 | 792.1 | Core part: NR_PC2_CA_R17_2BDL_2BUL |  | 460d | 2020-09-17 A | 2022-06-22 A | 100% |  |  |  | finish no earlier than 2022-06-22 | R4 | 3680h | 3680h | NR_PC2_CA_R17_2BDL_2BUL-Core | 45 | Liu, Bo, China Telecom | Rel-17 | 89 | liubo1@chinatelecom.cn | RP-221301 |  |  |
| 1773 | 792.2 | Perf. part: NR_PC2_CA_R17_2BDL_2BUL |  | 460d | 2020-09-17 A | 2022-06-22 A | 100% |  |  |  | finish no earlier than 2022-06-22 | R4 | 3680h | 3680h | NR_PC2_CA_R17_2BDL_2BUL-Perf | 45 | Liu, Bo, China Telecom | Rel-17 | 89 | liubo1@chinatelecom.cn | RP-221301 |  |  |
| 1774 | 792.3 | UE Conformance - Rel-17 High power UE for NR inter-band Carrier Aggregation with 2 bands downlink and x bands uplink (x=1,2) |  | 653d | 2021-06-15 A | 2023-12-12 A | 100% |  |  |  | finish no earlier than 2023-12-12 | R5 | 5224h | 5224h | NR_PC2_CA_R17_2BDL_2BUL-UEConTest | 47 | Jingzhou Wu, Dan Song, China Telecom, China Mobile | Rel-17 | 92 | wujingzhou@chinatelecom.cn, songdan@chinamobile.com | RP-233580 |  |  |
| 1775 | 793 | Rel-17 NR and LTE | manual | 125d | 2020-03-25 A | 2020-09-15 A | 100% |  |  |  |  |  |  |  |  |  |  | Rel-17 |  |  |  | 26.234; 26.247 |  |
| 1776 | 794 | **LTE/NR spectrum sharing in Band 34/n34 and Band 39/n39** |  | 0d | 2019-03-07 A | 2019-03-07 | 100% |  | 2022-03-11 |  |  | R4 | 1576h | 1576h | DSS_LTE_B34_NR_Bn34_LTE_B39_NR_Bn39 | 47 | CMCC | Rel-17 | 92 |  | RP-211995 |  |  |
| 1777 | 794.1 | Core part: LTE/NR spectrum sharing in Band 34/n34 and Band 39/n39 |  | 132d | 2021-06-15 A | 2021-12-15 A | 100% |  |  |  | finish no earlier than 2021-12-15 | R4 | 1056h | 1056h | DSS_LTE_B34_NR_Bn34_LTE_B39_NR_Bn39-Core | 47 | CMCC | Rel-17 | 92 |  |  |  |  |
| 1778 | 794.2 | UE Conformance - LTE/NR spectrum sharing in Band 34/n34 and Band 39/n39 |  | 65d | 2021-12-13 A | 2022-03-11 A | 100% |  |  |  | finish no earlier than 2022-12-12 | R5 | 520h | 520h | DSS_LTE_B34_NR_Bn34_LTE_B39_NR_Bn39-UEConTest | 48 | CMCC | Rel-17 | 94 |  | RP-220625 |  |  |
| 1779 | 795 | **High-power UE operation for fixed-wireless/vehicle-mounted use cases in LTE bands and NR bands** |  | 268d | 2021-06-15 A | 2022-06-22 A | 100% |  |  |  |  | R4 | 5880h | 5880h | LTE_NR_HPUE_FWVM | 47 | Nokia | Rel-17 | 92 |  |  |  |  |
| 1780 | 795.1 | Core part: High-power UE operation for fixed-wireless/vehicle-mounted use cases in LTE bands and NR bands |  | 267d | 2021-06-15 A | 2022-06-22 A | 100% |  |  |  | finish no earlier than 2022-06-22 | R4 | 2136h | 2136h | LTE_NR_HPUE_FWVM-Core | 47 | Vasenkari, Petri, Nokia | Rel-17 | 92 | Petri.j.vasenkari@nokia.com | RP-221199 / 1775 | 37.828; 37.828 |  |
| 1781 | 795.2 | Perf. Part: High-power UE operation for fixed-wireless/vehicle-mounted use cases in LTE bands and NR bands |  | 201d | 2021-09-15 A | 2022-06-22 A | 100% |  |  |  | finish no earlier than 2022-06-22 | R4 | 1608h | 1608h | LTE_NR_HPUE_FWVM-Perf | 47 | Vasenkari, Petri, Nokia | Rel-17 | 92 | Petri.j.vasenkari@nokia.com | RP-221199 / 1775 |  |  |
| 1782 | 796 | **Rel-17 Dual Connectivity (DC) of x bands (x=1,2) LTE inter-band CA (xDL1UL) and 4 bands NR inter-band CA (4DL1UL)** |  | 268d | 2021-06-15 A | 2022-06-22 A | 100% |  |  |  |  | R4 | 6408h | 6408h | DC_R17_xBLTE_4BNR_yDL2UL | 47 | Huawei | Rel-17 | 92 |  |  |  |  |
| 1783 | 796.1 | Core part: Rel-17 Dual Connectivity (DC) of x bands (x=1,2) LTE inter-band CA (xDL1UL) and 4 bands NR inter-band CA (4DL1UL) |  | 267d | 2021-06-15 A | 2022-06-22 A | 100% |  |  |  | finish no earlier than 2022-06-22 | R4 | 2136h | 2136h | DC_R17_xBLTE_4BNR_yDL2UL-Core | 47 | Zhang, Peng, Huawei | Rel-17 | 92 | zhangpeng169@huawei.com | RP-221523 |  |  |
| 1784 | 796.2 | Perf. part: Rel-17 Dual Connectivity (DC) of x bands (x=1,2) LTE inter-band CA (xDL1UL) and 4 bands NR inter-band CA (4DL1UL) |  | 267d | 2021-06-15 A | 2022-06-22 A | 100% |  |  |  | finish no earlier than 2022-06-22 | R4 | 2136h | 2136h | DC_R17_xBLTE_4BNR_yDL2UL-Perf | 47 | Zhang, Peng, Huawei | Rel-17 | 92 | zhangpeng169@huawei.com | RP-221523 |  |  |
| 1785 | 797 | **Addition of MSD (Maximum Sensitivity Degradation) for inter-band EN-DC combinations (1 band LTE+1 band NR FR1) due to added channel bandwidths** |  | 263d | 2021-03-25 A | 2022-03-25 A | 100% |  |  |  |  |  |  |  | ENDC_R17_1BLTE_1BNR_MSD | 46 | Huawei, HiSilicon | Rel-17 | 91 |  |  |  |  |
| 1786 | 797.1 | Core part: ENDC_R17_1BLTE_1BNR_MSD |  | 262d | 2021-03-25 A | 2022-03-25 A | 100% |  |  |  | finish no earlier than 2022-03-25 |  |  |  | ENDC_R17_1BLTE_1BNR_MSD-Core | 46 | Huawei, HiSilicon | Rel-17 | 91 |  |  |  |  |
| 1787 | 797.2 | Stopped - Perf. Part: ENDC_R17_1BLTE_1BNR_MSD |  | 262d | 2021-03-25 A | 2022-03-25 A | 100% |  |  |  | finish no earlier than 2022-03-25 |  |  |  | ENDC_R17_1BLTE_1BNR_MSD-Perf | 47 | Huawei, HiSilicon | Rel-17 | 93 |  |  |  | 96 |
| 1788 | 798 | **Rel-17 Power Class 2 for EN-DC with x LTE bands + y NR band(s) in DL and with 1 LTE band +1 TDD NR band in UL (either x= 2, 3, y=1 or x=1, 2, y=2)** |  | 849d | 2021-03-12 A | 2024-06-06 | 51% | 412.31d |  | 453d |  |  | 11056h | 5344h | ENDC_PC2_R17_xLTE_yNR | 46 | Ericsson | Rel-17 | 91 |  |  |  |  |
| 1789 | 798.1 | Core part: ENDC_PC2_R17_xLTE_yNR |  | 334d | 2021-03-12 A | 2022-06-22 A | 100% |  |  |  | finish no earlier than 2022-06-22 | R4 | 2672h | 2672h | ENDC_PC2_R17_xLTE_yNR-Core | 46 | Per Lindell, Ericsson | Rel-17 | 91 | per.lindell@ericsson.com | RP-221318 |  |  |
| 1790 | 798.2 | Perf. Part: ENDC_PC2_R17_xLTE_yNR |  | 334d | 2021-03-12 A | 2022-06-22 A | 100% |  |  |  | finish no earlier than 2022-06-22 | R4 | 2672h | 2672h | ENDC_PC2_R17_xLTE_yNR-Perf | 46 | Per Lindell, Ericsson | Rel-17 | 91 | per.lindell@ericsson.com | RP-221318 |  |  |
| 1791 | 798.3 | UE Conformance - Power Class 2 for EN-DC with x LTE bands + y NR band(s) in DL and with 1 LTE band +1 TDD NR band in UL (either x= 2, 3, y=1 or x=1, 2, y=2) |  | 714d | 2021-09-17 A | 2024-06-06 | 6% | 671.16d |  | 453d | finish no earlier than 2024-06-06 | R5 | 5712h |  | ENDC_PC2_R17_xLTE_yNR-UEConTest | 47 | Kuba KOLODZIEJ, Ericsson | Rel-17 | 93 | Kuba[dot]kolodziej[at]ericsson[dot]com | RP-240072 |  |  |

Notes:
- 1768: 25/9/20: WID:RP-201027->RP-201724; 6/1/21: WID:RP-201724->RP-202609; 7/4/21: WID:RP-202609->RP-210561; 2/7/21: WID:RP-210561->RP-211373; 29/9/21: WID:RP-211373->RP-212176; 6/1/22: WID:RP-212176->RP-213129; 5/4/22: WID:RP-213129->RP-220692; 12/7/22: WID:RP-220692->RP-221510
- 1769: ; 13/9/21: Compl:0%->15%; ; 22/3/22: Compl:15%->40%; 22/3/22: 20/6/22: Rapporteur: Huawei->Zhang, Peng, Huawei; Rap eMail: ->zhangpeng169@huawei.com;
- 1770: ; 13/9/21: Compl:0%->15%; ; 22/3/22: Compl:15%->40%; 22/3 20/6/22: Rapporteur: Huawei->Zhang, Peng, Huawei; Rap eMail: ->zhangpeng169@huawei.com;
- 1771: basket WI; related to generic WI NR_SAR_PC2_interB_SUL_2BUL-Core; TR 38.8xx ; 6/1/21: WID:RP-202102->RP-202373; 7/4/21: WID:RP-202373->RP-210476; 2/7/21: WID:RP-210476->RP-211131; 2/7/21: 38.841 added;; 29/9/21: WID:RP-211131->RP-211831; 6/1/22: WID:RP ; 12/7/22: WID:RP-220567->RP-221866
- 1772: basket WI; related to generic WI NR_SAR_PC2_interB_SUL_2BUL-Core; TR 38.8xx ; 13/9/21: Compl:0%->70%; 13/9/21: CD:Fri 17/12/21->Tue 22/03/22; 13/9/21: WID: RP-211 ; 20/6/22: WID: RP-202102 RP-202373 RP-210476 RP-211131 RP-211831 RP_213649 RP-220...
- 1773: basket WI ; 13/9/21: CD:Fri 17/12/21->Tue 22/03/22; 13/9/21: WID: RP-211131->RP-202102 RP-202373 RP-210476 RP-211131; 13/9/21: Stat Rep: ->RP-211832; 22/3/22: CD:22/03/2022->12/06/2022; 22/3/22: WID: RP-213649->RP_213649; 22/3/22: Stat Rep: RP-211832- ; 20/6/22: WID: RP-202102 RP-202373 RP-210476 RP-211131 RP-211831 RP_213649 RP-220567->RP-220567; Rapporteur: China Telecom->Liu, Bo, China Telecom; Rap eMail: ->liubo1@chinatelecom.cn;
- 1774: tested: REL-17 WI NR_PC2_CA_R17_2BDL_2BUL-Core ; 13/9/21: Compl:0%->15%; 13/9/21: CD:Tue 15/03/22->Tue 22/03/22; 1 ; 22/3/22: Compl:15%->18%; 20/6/22: Rapporteur: China Telecom->Jingzhou Wu, China Telecom; Rap eMail: ->wujingzhou@chinatelecom.cn...;...; 2/1/24: WID:RP-211140->RP-233581
- 1776: compare REL-17 WI NR_DSS; no Perf. part ; 13/9/21: Compl:0%->100% ;
- 1777: compare REL-17 WI NR_DSS; no Perf. part ; 29/9/21: WID:RP-211509->RP-211996
- 1778: tested: REL-17 WI DSS_LTE_B34_NR_Bn34_LTE_B39_NR_Bn39-Core;
- 1779: this is not a basket WI ; 29/9/21: WID:RP-211571->RP-212533; 6/1/22: WID:RP-212533->RP-213106; 5/4/22: WID:RP-213106->RP-220767; 12/7/22: WID:RP-220767->RP-221795
- 1780: this is not a basket WI ; 13/9/21: CD:Tue 15/03/22->Tue 22/03/22; …; 7/1/22: 37.828 and 37.828 added;; 22/3/22: Compl:0%->50% ; 20/6/22: Compl:50%->100%; Stat Rep: RP-221199->RP-221199 / 1775; Rapporteur: Nokia->Vasenkari, Petri, Nokia; Rap eMail...
- 1781: this is not a basket WI ; 13/9/21: CD:Wed 15/06/22->Wed 22/06/22; ; 22/3/22: Compl:0%->50% ; 20/6/22: FCD:22/09/2022->22/06/2022; Stat Rep: RP-221199->RP-221199 / 1775; Rapporteur: Nokia->Vasenkari, Petri, Nokia; Rap eMail: ->Petri.j.vasenkari@n...
- 1782: basket WI; TR 37.717-11-41 ; 29/9/21: WID:RP-211592->RP-212606; 6/1/22: WID:RP-212606->RP-213142; 5/4/22: WID:RP-213142->RP-220712; 12/7/22: WID:RP-220712->RP-221524
- 1783: basket WI; TR 37.717-11-41 ; 20/6/22: FCD:15/03/2022->22/06/2022; Compl:0%->100%; Stat Rep: ->RP-221523; Rapporteur: Huawei->Zhang, Peng, Huawei; Rap eMail: ->zhangpeng169@huawei.com;
- 1784: basket WI ; 22/3/22: Compl:0%->15%; 22/3/22: CD:15/03/2022->10/06/2022; 20/6/22: Rapporteur: Huawei->Zhang, Peng, Huawei; Rap eMail: ->zhangpeng169@huawei.com;
- 1785: basket WI; addition of MSD requirement for cases where new channel bandwidths were added; no Perf. Part; 2/7/21: WID:RP-210891->RP-211384; 29/9/21: WID:RP-211384->RP-212187; 6/1/22: WID:RP-212187->RP-213140; 5/4/22: WID:RP-213140->RP-220709
- 1786: 20/6/22: WG: ->R4; FCD:25/03/2022->22/03/2023; Compl:0%->100%; WID: RP-220709->RP-213140; Stat Rep: ->RP-220858; Rapporteur: Huawei, HiSilicon->Zhang, Peng; Rap eMail: ->zhangpeng169@huawei.com20/6/22: 0%->100
- 1787: 4/6/22: Stopped at 70%. This Perf. part is not needed
- 1788: basket WI; compare REL-16 WI ENDC_UE_PC2_TDD_TDD and REL-16 WI ENDC_UE_PC2_FDD_TDD; TR 37.8xx ; 2/7/21: WID:RP-210816->RP-211172; 29/9/21: WID:RP-211172->RP-211760; 6/1/22: WID:RP-211760->RP-213467; 5/4/22: WID:RP-213467->RP-220828; 12/7/22: WID:RP-220828->RP-221322
- 1789: basket WI; compare REL-16 WI ENDC_UE_PC2_TDD_TDD and REL-16 WI ENDC_UE_PC2_FDD_TDD; TR 37.8xx ; 2/7/21: 37.827 added; ; 20/6/22: Rapporteur: Ericsson->Per Lindell, Ericsson; Rap eMail: ->per.lindell@ericsson.com; List of Impacted TS & TR updated;
- 1790: compare REL-16 WI ENDC_UE_PC2_TDD_TDD and REL-16 WI ENDC_UE_PC2_FDD_TDD ; 20/6/22: Rapporteur: Ericsson->Per Lindell, Ericsson; Rap eMail: ->per.lindell@ericsson.com;
- 1791: tested: REL-17 WI ENDC_PC2_R17_xLTE_yNR ; 22/3/22: Compl:0%->5%; 22/3/22: CD:15/12/2022->12/12/2022; 22/3/22 6/6/22: CD:12/12/2022->22/12/2022 ; ; 20/6/22: Rapporteur: Ericsson->Leif MATTISSON, Ericsson; Rap eMail: ->Leif[dot]mattisson[at]ericsson[d...; 2/4/24: WID:RP-230082->RP-240074

| ID | WBS | Task | Duration | Start | Finish | Complete | Constraint | Resources | Work | Actual work | Acronym | PCG approved | WI rapporteur name | Release | TSG approved | Impacted TSs and TRs | WI rapporteur e-mail | Status Report | TSG stopped |
| --- | --- | --- | --- | --- | --- | --- | --- | --- | --- | --- | --- | --- | --- | --- | --- | --- | --- | --- | --- |
| 1792 | 799 | **Simultaneous Rx/Tx band combinations for NR CA/DC, NR SUL and LTE/NR DC** | 335d | 2021-03-12 A | 2022-06-22 A | 100% |  |  | 5344h | 5344h | LTE_NR_Simult_RxTx | 46 | Huawei | Rel-17 | 91 |  |  |  |  |
| 1793 | 799.1 | Core part: LTE_NR_Simult_RxTx | 334d | 2021-03-12 A | 2022-06-22 A | 100% | finish no earlier than 2022-06-22 | R4 | 2672h | 2672h | LTE_NR_Simult_RxTx-Core | 46 | Liu Ye, Huawei | Rel-17 | 91 | 38.839 | leo.liuye@huawei.com | RP-221520 |  |
| 1794 | 799.2 | Stopped - Perf. part: LTE_NR_Simult_RxTx | 334d | 2021-03-12 A | 2022-06-22 A | 100% | finish no earlier than 2022-06-22 | R4 | 2672h | 2672h | LTE_NR_Simult_RxTx-Perf | 46 | Liu Ye, Huawei | Rel-17 | 91 |  | leo.liuye@huawei.com | RP-221520 | 96 |
| 1795 | 800 | **Rel-17 Dual Connectivity (DC) of 5 bands LTE inter-band CA (5DL/1UL) and 1 NR band (1DL/1UL)** | 388d | 2020-09-17 A | 2022-03-11 A | 100% |  |  | 6192h | 6192h | DC_R17_5BLTE_1BNR_6DL2UL | 45 | Samsung | Rel-17 | 89 |  |  |  |  |
| 1796 | 800.1 | Core part: DC_R17_5BLTE_1BNR_6DL2UL | 387d | 2020-09-17 A | 2022-03-11 A | 100% | finish no earlier than 2022-03-22 | R4 | 3096h | 3096h | DC_R17_5BLTE_1BNR_6DL2UL-Core | 45 | Samsung | Rel-17 | 89 |  |  | RP-220673 |  |
| 1797 | 800.2 | Perf. part: DC_R17_5BLTE_1BNR_6DL2UL | 387d | 2020-09-17 A | 2022-03-11 A | 100% | finish no earlier than 2022-03-22 | R4 | 3096h | 3096h | DC_R17_5BLTE_1BNR_6DL2UL-Perf | 45 | Samsung | Rel-17 | 89 |  |  | RP-220673 |  |
| 1798 | 801 | **Rel-17 Dual Connectivity (DC) of x bands (x=2, 3, 4) LTE inter-band CA (xDL/1UL) and 1 NR FR1 band (1DL/1UL) and 1 NR FR2 band (1DL/1UL)** | 388d | 2020-09-17 A | 2022-03-11 A | 100% |  |  | 6192h | 6192h | DC_R17_xBLTE_2BNR_yDL3UL | 45 | Samsung | Rel-17 | 89 |  |  |  |  |
| 1799 | 801.1 | Core part: DC_R17_xBLTE_2BNR_yDL3UL | 387d | 2020-09-17 A | 2022-03-11 A | 100% | finish no earlier than 2022-03-22 | R4 | 3096h | 3096h | DC_R17_xBLTE_2BNR_yDL3UL-Core | 45 | Samsung | Rel-17 | 89 |  |  | RP-220675 |  |
| 1800 | 801.2 | Perf. part: DC_R17_xBLTE_2BNR_yDL3UL | 387d | 2020-09-17 A | 2022-03-11 A | 100% | finish no earlier than 2022-03-22 | R4 | 3096h | 3096h | DC_R17_xBLTE_2BNR_yDL3UL-Perf | 45 | Samsung | Rel-17 | 89 |  |  | RP-220675 |  |
| 1801 | 802 | **Band combinations for concurrent operation of NR/LTE Uu bands/band combinations and one NR/LTE V2X PC5 band** | 524d | 2020-06-22 A | 2022-06-22 A | 100% |  |  | 8368h | 8368h | NR_LTE_V2X_PC5_combos | 45 | CATT | Rel-17 | 88 | 37.875 |  |  |  |
| 1802 | 802.1 | Core part: NR_LTE_V2X_PC5_combos | 523d | 2020-06-22 A | 2022-06-22 A | 100% | finish no earlier than 2022-06-22 | R4 | 4184h | 4184h | NR_LTE_V2X_PC5_combos-Core | 45 | Yuan Gao, CATT | Rel-17 | 88 | 37.875 | gaoyuan@catt.cn | RP-221461 |  |
| 1803 | 802.2 | Perf. part: NR_LTE_V2X_PC5_combos | 523d | 2020-06-22 A | 2022-06-22 A | 100% | finish no earlier than 2022-06-22 | R4 | 4184h | 4184h | NR_LTE_V2X_PC5_combos-Perf | 45 | Yuan Gao, CATT | Rel-17 | 88 | 37.875 | gaoyuan@catt.cn | RP-221461 |  |
| 1804 | 803 | **High power UE (power class 2) for EN-DC with 1 LTE band + 1 NR TDD band** | 773d | 2020-06-22 A | 2023-06-06 A | 100% |  |  | 13040h | 13040h | ENDC_UE_PC2_R17_NR_TDD | 45 | China Unicom | Rel-17 | 88 |  |  |  |  |
| 1805 | 803.1 | Core part: ENDC_UE_PC2_R17_NR_TDD | 523d | 2020-06-22 A | 2022-06-22 A | 100% | finish no earlier than 2022-06-22 | R4 | 4184h | 4184h | ENDC_UE_PC2_R17_NR_TDD-Core | 45 | Basaier Jialade, China Unicom | Rel-17 | 88 |  | basejld@chinaunicom.cn | RP-221228 |  |
| 1806 | 803.2 | Perf. part: ENDC_UE_PC2_R17_NR_TDD | 523d | 2020-06-22 A | 2022-06-22 A | 100% | finish no earlier than 2022-06-22 | R4 | 4184h | 4184h | ENDC_UE_PC2_R17_NR_TDD-Perf | 45 | Basaier Jialade, China Unicom | Rel-17 | 88 |  | basejld@chinaunicom.cn | RP-221228 |  |
| 1807 | 803.3 | UE Conformance - ENDC_UE_PC2_R17_NR_TDD | 584d | 2021-03-12 A | 2023-06-06 A | 100% | finish no earlier than 2023-06-06 | R5 | 4672h | 4672h | ENDC_UE_PC2_R17_NR_TDD-UEConTest | 46 | Shi，Yu, China Unicom | Rel-17 | 91 |  | shiyu19@chinaunicom.cn | RP-230698 |  |
| 1808 | 804 | **LTE/NR spectrum sharing in Band 38/n38** | 65d | 2020-06-17 A | 2020-09-15 A | 100% |  |  | 520h | 520h | DSS_LTE_B38_NR_Bn38 | 45 | Vodafone | Rel-17 | 88 |  |  |  |  |
| 1809 | 804.1 | Core part: DSS_LTE_B38_NR_Bn38 | 65d | 2020-06-17 A | 2020-09-15 A | 100% | finish no earlier than 2020-09-15 | R4 | 520h | 520h | DSS_LTE_B38_NR_Bn38-Core | 45 | Vodafone | Rel-17 | 88 |  |  |  |  |
| 1810 | 805 | **LTE/NR spectrum sharing in Band 40/n40** | 65d | 2020-06-17 A | 2020-09-15 A | 100% |  |  | 1040h | 1040h | DSS_LTE_B40_NR_Bn40 | 45 | Reliance Jio | Rel-17 | 88 |  |  |  |  |
| 1811 | 805.1 | Core part: DSS_LTE_B40_NR_Bn40 | 65d | 2020-06-17 A | 2020-09-15 A | 100% | finish no earlier than 2020-09-15 | R4 | 520h | 520h | DSS_LTE_B40_NR_Bn40-Core | 45 | Reliance Jio | Rel-17 | 88 |  |  |  |  |
| 1812 | 805.2 | Perf. part: DSS_LTE_B40_NR_Bn40 | 65d | 2020-06-17 A | 2020-09-15 A | 100% | finish no earlier than 2020-09-15 | R4 | 520h | 520h | DSS_LTE_B40_NR_Bn40-Perf | 45 | Reliance Jio | Rel-17 | 88 |  |  |  |  |
| 1813 | 806 | **Dual Connectivity (DC) of 1 LTE band (1DL/1UL) and 1 NR band (1DL/1UL)** | 524d | 2020-06-22 A | 2022-06-22 A | 100% |  |  | 8368h | 8368h | DC_R17_1BLTE_1BNR_2DL2UL | 45 | CHTTL | Rel-17 | 88 |  |  |  |  |
| 1814 | 806.1 | Core part: DC_R17_1BLTE_1BNR_2DL2UL | 523d | 2020-06-22 A | 2022-06-22 A | 100% | finish no earlier than 2022-06-22 | R4 | 4184h | 4184h | DC_R17_1BLTE_1BNR_2DL2UL-Core | 45 | Bo-Han Hsieh (Tank), CHTTL | Rel-17 | 88 |  | pohanhsieh@cht.com.tw | RP-221256 |  |
| 1815 | 806.2 | Perf. part: DC_R17_1BLTE_1BNR_2DL2UL | 523d | 2020-06-22 A | 2022-06-22 A | 100% | finish no earlier than 2022-06-22 | R4 | 4184h | 4184h | DC_R17_1BLTE_1BNR_2DL2UL-Perf | 45 | Bo-Han Hsieh (Tank), CHTTL | Rel-17 | 88 |  | pohanhsieh@cht.com.tw | RP-221256 |  |

Notes:
- 1792: ; 2/7/21: WID:RP-210890->RP-211382; 5/4/22: WID:RP-211382->RP-220707; 12/7/22: WID:RP-220707->RP-221521
- 1793: ; 13/9/21: Compl:0%->70% ; 1/10/21: 38.839 added; ; 20/6/22: Rapporteur: Huawei->Liu Ye, Huawei; Rap eMail: ->leo.liuye@huawei.com;
- 1794: ; 13/9/21: Compl:0%->70% ; 6/6/22: Compl:70%->0%6/6/22: CD:22/03/2022->22/06/20226/6/22: WID: RP-220707->RP-2113826/6/22: Stat Rep: RP-212185->RP-221520; 20/6/22: Compl:0%->100%; Rapporteur: Huawei->Liu Ye, Huawei; Rap eMail: ->leo.liuye@huawei.com; Sto
- 1795: basket WI; TR 37.717-51-11 ; 6/1/21: WID:RP-201642->RP-202540; 7/4/21: WID:RP-202540->RP-210801; 2/7/21: WID:RP-210801->RP-211195; 6/1/22: WID:RP-211195->RP-213112; 5/4/22: WID:RP-213112->RP-220672
- 1796: basket WI; TR 37.717-51-11 ; 13/9/21: Compl:0%->70% ; ;
- 1797: basket WI ; 13/9/21: Compl:0%->70%; ;
- 1798: basket WI; TR 37.717-21-22 ; 6/1/21: WID:RP-201643->RP-202542; 5/4/22: WID:RP-202542->RP-220674
- 1799: basket WI; TR 37.717-21-22 ; 13/9/21: Compl:0%->70% ; ;
- 1800: basket WI ; 13/9/21: Compl:0%->70%; ;
- 1801: 25/9/20: WID:RP-200924->RP-201789; 25/9/20: 37.875 added;; 7/4/21: WID:RP-201789->RP-210588; 6/1/22: WID:RP-210588->RP-213297
- 1802: 25/9/20: 37.875 added;; 22/3/22: Compl:0%->95%; 20/6/22: Rapporteur: CATT->Yuan Gao, CATT; Rap eMail: ->gaoyuan@catt.cn;
- 1803: 25/9/20: 37.875 added;; 22/3/22: Compl:0%->9 20/6/22: Rapporteur: CATT->Yuan Gao, CATT; Rap eMail: ->gaoyuan@catt.cn;
- 1804: 25/9/20: WID:RP-201328->RP-202079; 6/1/21: WID:RP-202079->RP-202838; 7/4/21: WID:RP-202838->RP-210327; 2/7/21: WID:RP-210327->RP-211073; 29/9/21: WID:RP-211073->RP-211853; 5/4/22: WID:RP-211853->RP-220388; 12/7/22: WID:RP-220388->RP-221227
- 1805: ; 13/9/21: Compl:0%->40%; 13/9/21: CD:Wed 15/09/21->Tue 22/03/22; 13/9/21: Stat Rep: ->RP-211852; 22/3/2 20/6/22: Rapporteur: China Unicom->Basaier Jialade, China Unicom; Rap eMail: ->basejld@chinaunicom.cn;
- 1806: ; 13/9/21: Compl:0%->40%; 13/9/21: CD:Wed 15/09/21->Tue 22/03/22; 13/9/21: Stat Rep: ->RP-211852; 22/3 20/6/22: Rapporteur: China Unicom->Basaier Jialade, China Unicom; Rap eMail: ->basejld@chinaunicom.cn;
- 1807: tested: REL-17 basket WI ENDC_UE_PC2_R17_NR_TDD-Core ; 2/7/21: WID:RP-210401->RP-211420; 2/7/21: 0%->10 ; ; 6/6/22: Com ; 20/6/22: Rapporteur: China Unicom->Shi，Yu, China Unicom; Rap eMail: ->shiyu19@chinaunicom.cn ; ;...; 9/12/22: FCD:23/03/2023->01...; ; ; ; ; ; ; ; ; ; ; ; ; ; ; ; ; ; ; ; 7/6/23: Compl:55%->100%
- 1809: 25/9/20: 0%->100
- 1810: 25/9/20: WID:RP-201362->RP-202084
- 1811: 6/1/21: 0%->100
- 1812: 25/9/20: 0%->100
- 1813: 25/9/20: WID:RP-201368->RP-201553; 6/1/21: WID:RP-201553->RP-202545; 7/4/21: WID:RP-202545->RP-210204; 2/7/21: WID:RP-210204->RP-211162; 29/9/21: WID:RP-211162->RP-212096; 6/1/22: WID:RP-212096->RP-213060; 5/4/22: WID:RP-213060->RP-220398; 12/7/22: WID:RP-220398->RP-221257
- 1814: ; 13/9/21: Compl:0%->75%; ; 22/3/22: Compl:75%->90%; 20/6/22: Rapporteur: CHTTL->Bo-Han Hsieh (Tank), CHTTL; Rap eMail: ->pohanhsieh@cht.com.tw;
- 1815: ; 13/9/21: CD:Wed 15/09/21->Tue 22/03/22; ; 22/3/22: Compl:0%->90%; ; 20/6/22: Rapporteur: CHTTL->Bo-Han Hsieh (Tank), CHTTL; Rap eMail: ->pohanhsieh@cht.com.tw;

| ID | WBS | Task | Type | Duration | Start | Finish | Complete | Remaining | Total slack | Constraint | Resources | Work | Actual work | Acronym | PCG approved | WI rapporteur name | Release | TSG approved | WI rapporteur e-mail | Status Report | Impacted TSs and TRs |
| --- | --- | --- | --- | --- | --- | --- | --- | --- | --- | --- | --- | --- | --- | --- | --- | --- | --- | --- | --- | --- | --- |
| 1816 | 807 | **Dual Connectivity (DC) of 2 bands LTE inter-band CA (2DL/1UL) and 1 NR band (1DL/1UL)** |  | 524d | 2020-06-22 A | 2022-06-22 A | 100% |  |  |  |  | 7872h | 7872h | DC_R17_2BLTE_1BNR_3DL2UL | 45 | Huawei | Rel-17 | 88 |  |  |  |
| 1817 | 807.1 | Core part: DC_R17_2BLTE_1BNR_3DL2UL |  | 523d | 2020-06-22 A | 2022-06-22 A | 100% |  |  | finish no earlier than 2022-06-22 | R4 | 4184h | 4184h | DC_R17_2BLTE_1BNR_3DL2UL-Core | 45 | Liehai Liu, Huawei | Rel-17 | 88 | liuliehai@huawei.com | RP-221507 |  |
| 1818 | 807.2 | Perf. part: DC_R17_2BLTE_1BNR_3DL2UL |  | 461d | 2020-09-16 A | 2022-06-22 A | 100% |  |  | finish no earlier than 2022-06-22 | R4 | 3688h | 3688h | DC_R17_2BLTE_1BNR_3DL2UL-Perf | 45 | Liehai Liu, Huawei | Rel-17 | 89 | liuliehai@huawei.com | RP-221507 |  |
| 1819 | 808 | **Dual Connectivity (DC) of 3 bands LTE inter-band CA (3DL/1UL) and 1 NR band (1DL/1UL)** |  | 524d | 2020-06-22 A | 2022-06-22 A | 100% |  |  |  |  | 8368h | 8368h | DC_R17_3BLTE_1BNR_4DL2UL | 45 | Ericsson | Rel-17 | 88 |  |  |  |
| 1820 | 808.1 | Core part: DC_R17_3BLTE_1BNR_4DL2UL |  | 523d | 2020-06-22 A | 2022-06-22 A | 100% |  |  | finish no earlier than 2022-06-22 | R4 | 4184h | 4184h | DC_R17_3BLTE_1BNR_4DL2UL-Core | 45 | Per Lindell, Ericsson | Rel-17 | 88 | per.lindell@ericsson.com | RP-221315 |  |
| 1821 | 808.2 | Perf. part: DC_R17_3BLTE_1BNR_4DL2UL |  | 523d | 2020-06-22 A | 2022-06-22 A | 100% |  |  | finish no earlier than 2022-06-22 | R4 | 4184h | 4184h | DC_R17_3BLTE_1BNR_4DL2UL-Perf | 45 | Per Lindell, Ericsson | Rel-17 | 88 | per.lindell@ericsson.com | RP-221315 |  |
| 1822 | 809 | **Dual Connectivity (DC) of 4 bands LTE inter-band CA (4DL/1UL) and 1 NR band (1DL/1UL)** |  | 524d | 2020-06-22 A | 2022-06-22 A | 100% |  |  |  |  | 8368h | 8368h | DC_R17_4BLTE_1BNR_5DL2UL | 45 | Nokia | Rel-17 | 88 |  |  |  |
| 1823 | 809.1 | Core part: DC_R17_4BLTE_1BNR_5DL2UL |  | 523d | 2020-06-22 A | 2022-06-22 A | 100% |  |  | finish no earlier than 2022-06-22 | R4 | 4184h | 4184h | DC_R17_4BLTE_1BNR_5DL2UL-Core | 45 | Johannes Hejselbaek, Nokia | Rel-17 | 88 | johannes.hejselbaek@nokia.com | RP-221072 |  |
| 1824 | 809.2 | Perf. part: DC_R17_4BLTE_1BNR_5DL2UL |  | 523d | 2020-06-22 A | 2022-06-22 A | 100% |  |  | finish no earlier than 2022-06-22 | R4 | 4184h | 4184h | DC_R17_4BLTE_1BNR_5DL2UL-Perf | 45 | Johannes Hejselbaek, Nokia | Rel-17 | 88 | johannes.hejselbaek@nokia.com | RP-221072 |  |
| 1825 | 810 | **Dual Connectivity (DC) of x bands (x=1,2,3,4) LTE inter-band CA (xDL/1UL) and 2 bands NR inter-band CA (2DL/1UL)** |  | 524d | 2020-06-22 A | 2022-06-22 A | 100% |  |  |  |  | 8368h | 8368h | DC_R17_xBLTE_2BNR_yDL2UL | 45 | LG Electronics | Rel-17 | 88 |  |  |  |
| 1826 | 810.1 | Core part: DC_R17_xBLTE_2BNR_yDL2UL |  | 523d | 2020-06-22 A | 2022-06-22 A | 100% |  |  | finish no earlier than 2022-06-22 | R4 | 4184h | 4184h | DC_R17_xBLTE_2BNR_yDL2UL-Core | 45 | Sang-Wook Lee, LG Electronics | Rel-17 | 88 | sangwook1.lee@lge.com | RP-221183 |  |
| 1827 | 810.2 | Perf. part: DC_R17_xBLTE_2BNR_yDL2UL |  | 523d | 2020-06-22 A | 2022-06-22 A | 100% |  |  | finish no earlier than 2022-06-22 | R4 | 4184h | 4184h | DC_R17_xBLTE_2BNR_yDL2UL-Perf | 45 | Sang-Wook Lee, LG Electronics | Rel-17 | 88 | sangwook1.lee@lge.com | RP-221183 |  |
| 1828 | 811 | **Dual Connectivity (DC) of x bands (x=1,2) LTE inter-band CA (xDL/xUL) and y bands (y=3-x) NR inter-band CA (yDL/yUL)** |  | 524d | 2020-06-22 A | 2022-06-22 A | 100% |  |  |  |  | 8368h | 8368h | DC_R17_xBLTE_yBNR_3DL3UL | 45 | ZTE | Rel-17 | 88 |  |  |  |
| 1829 | 811.1 | Core part: DC_R17_xBLTE_yBNR_3DL3UL |  | 523d | 2020-06-22 A | 2022-06-22 A | 100% |  |  | finish no earlier than 2022-06-22 | R4 | 4184h | 4184h | DC_R17_xBLTE_yBNR_3DL3UL-Core | 45 | Wubin Zhou, ZTE | Rel-17 | 88 | zhou.wubin@zte.com.cn | RP-221233 |  |
| 1830 | 811.2 | Perf. part: DC_R17_xBLTE_yBNR_3DL3UL |  | 523d | 2020-06-22 A | 2022-06-22 A | 100% |  |  | finish no earlier than 2022-06-22 | R4 | 4184h | 4184h | DC_R17_xBLTE_yBNR_3DL3UL-Perf | 45 | Wubin Zhou, ZTE | Rel-17 | 88 | zhou.wubin@zte.com.cn | RP-221233 |  |
| 1831 | 812 | **Dual Connectivity (DC) of x bands (x=1,2,3) LTE inter-band CA (xDL/1UL) and 3 bands NR inter-band CA (3DL/1UL)** |  | 524d | 2020-06-22 A | 2022-06-22 A | 100% |  |  |  |  | 8368h | 8368h | DC_R17_xBLTE_3BNR_yDL2UL | 45 | ZTE | Rel-17 | 88 |  |  |  |
| 1832 | 812.1 | Core part: DC_R17_xBLTE_3BNR_yDL2UL |  | 523d | 2020-06-22 A | 2022-06-22 A | 100% |  |  | finish no earlier than 2022-06-22 | R4 | 4184h | 4184h | DC_R17_xBLTE_3BNR_yDL2UL-Core | 45 | Wubin Zhou, ZTE | Rel-17 | 88 | zhou.wubin@zte.com.cn | RP-221236 |  |
| 1833 | 812.2 | Perf. part: DC_R17_xBLTE_3BNR_yDL2UL |  | 523d | 2020-06-22 A | 2022-06-22 A | 100% |  |  | finish no earlier than 2022-06-22 | R4 | 4184h | 4184h | DC_R17_xBLTE_3BNR_yDL2UL-Perf | 45 | Wubin Zhou, ZTE | Rel-17 | 88 | zhou.wubin@zte.com.cn | RP-221236 |  |
| 1834 | 813 | **band combinations for SA NR supplementary uplink (SUL), NSA NR SUL, NSA NR SUL with UL sharing from the UE perspective (ULSUP)** |  | 524d | 2020-06-22 A | 2022-06-22 A | 100% |  |  |  |  | 8368h | 8368h | NR_SUL_combos_R17 | 45 | Huawei | Rel-17 | 88 |  |  |  |
| 1835 | 813.1 | Core part: NR_SUL_combos_R17 |  | 523d | 2020-06-22 A | 2022-06-22 A | 100% |  |  | finish no earlier than 2022-06-22 | R4 | 4184h | 4184h | NR_SUL_combos_R17-Core | 45 | Zhang, Peng, Huawei | Rel-17 | 88 | zhangpeng169@huawei.com | RP-221511 |  |
| 1836 | 813.2 | Perf. part: NR_SUL_combos_R17 |  | 523d | 2020-06-22 A | 2022-06-22 A | 100% |  |  | finish no earlier than 2022-06-22 | R4 | 4184h | 4184h | NR_SUL_combos_R17-Perf | 45 | Zhang, Peng, Huawei | Rel-17 | 88 | zhangpeng169@huawei.com | RP-221511 |  |
| 1837 | 814 | UE Conformance - Rel-17 NR CA and DC; and NR and LTE DC Configurations |  | 1048d | 2020-12-14 A | 2024-12-12 | 11% | 932.72d | 318d | finish no earlier than 2024-12-12 | R5 | 8384h |  | NR_CADC_NR_LTE_DC_R17-UEConTest | 46 | Yuxin Hao, Huawei Technologies. Co., Ltd. | Rel-17 | 90 | haoyuxin@huawei.com | RP-240277 |  |
| 1838 | 815 | Rel-17 NR new/modified bands | milestone, manual | 0d | 2016-06-09 A | 2016-06-09 A | 100% |  |  |  |  |  |  |  |  |  | Rel-17 |  |  |  | 26.234; 26.247 |
| 1839 | 816 | **Introduction of 900MHz NR band for Europe for Rail Mobile Radio (RMR)** |  | 401d | 2021-03-12 A | 2022-09-22 A | 100% |  |  |  |  | 5872h | 5872h | NR_RAIL_EU_900MHz | 46 | Union Internationale Chemins de Fer (UIC) | Rel-17 | 91 |  |  |  |
| 1840 | 816.1 | Core part: NR_RAIL_EU_900MHz |  | 400d | 2021-03-12 A | 2022-09-22 A | 100% |  |  | finish no earlier than 2023-03-22 | R4 | 3200h | 3200h | NR_RAIL_EU_900MHz-Core | 46 | Ingo Wendler, UIC | Rel-17 | 91 | ingo dot wendler at sbb dot ch | RP-221071/1071/1808/1816 | 38.853 |
| 1841 | 816.2 | Perf. part: NR_RAIL_EU_900MHz |  | 334d | 2021-03-12 A | 2022-06-22 A | 100% |  |  | finish no earlier than 2023-03-22 | R4 | 2672h | 2672h | NR_RAIL_EU_900MHz-Perf | 46 | Ingo Wendler, UIC | Rel-17 | 91 | ingo dot wendler at sbb dot ch | RP-221071/1071/1808/1816 |  |

Notes:
- 1816: 25/9/20: WID:RP-201369->RP-202060; 6/1/21: WID:RP-202060->RP-202613; 7/4/21: WID:RP-202613->RP-210559; 2/7/21: WID:RP-210559->RP-211371; 29/9/21: WID:RP-211371->RP-212174; 6/1/22: WID:RP-212174->RP-213127; 5/4/22: WID:RP-213127->RP-220689; 12/7/22: WID:RP-220689->RP-221508
- 1817: ; 13/9/21: Compl:0%->60%; ; 22/3/22: Compl:60%->85%; 20/6/22: Rapporteur: Huawei->Liehai Liu, Huawei; Rap eMail: ->liuliehai@huawei.com;
- 1818: 20/6/22: FCD:15/09/2021->22/06/2022; Compl:0%->100%; Stat Rep: ->RP-221507; Rapporteur: Huawei->Liehai Liu, Huawei; Rap eMail: ->liuliehai@huawei.com;
- 1819: 25/9/20: WID:RP-201370->RP-201572; 6/1/21: WID:RP-201572->RP-202188; 7/4/21: WID:RP-202188->RP-210211; 2/7/21: WID:RP-210211->RP-211170; 29/9/21: WID:RP-211170->RP-211758; 6/1/22: WID:RP-211758->RP-212901; 5/4/22: WID:RP-212901->RP-220826; 12/7/22: WID:RP-220826->RP-221320
- 1820: 13/9/21: Compl:0%->74%13/9/21: CD:Wed 15/09/21->Tue 22/03/2213/9/21: Stat Rep: ->RP-211753 ; 20/6/22: Rapporteur: Ericsson->Per Lindell, Ericsson; Rap eMail: ->per.lindell@ericsson.com;
- 1821: 13/9/21: Compl:0%->74%13/9/21: CD:Wed 15/09/21->Tue 22/03/2213/9/21: Stat Rep: ->RP-211753 ; 20/6/22: Rapporteur: Ericsson->Per Lindell, Ericsson; Rap eMail: ->per.lindell@ericsson.com;
- 1822: 25/9/20: WID:RP-201371->RP-201483; 6/1/21: WID:RP-201483->RP-202590; 7/4/21: WID:RP-202590->RP-210766; 2/7/21: WID:RP-210766->RP-211319; 29/9/21: WID:RP-211319->RP-212532; 6/1/22: WID:RP-212532->RP-213251; 5/4/22: WID:RP-213251->RP-220999; 12/7/22: WID:RP-220999->RP-221073
- 1823: ; 13/9/21: Compl:0%->60%; 13/9/21: CD:Wed 15/09/21->Tue 22/03/22; 13/9/21: Stat Rep: ->RP-211820; 20/6/22: Stat Rep: RP-221151->RP-221072; Rapporteur: Nokia->Johannes Hejselbaek, Nokia; Rap eMail: ->johannes.hejselbaek@nokia.com;
- 1824: ; 13/9/21: Compl:0%->60%; 13/9/21: CD:Wed 15/09/21->Tue 22/03/22; 13/9/21: Stat Rep: ->RP-211820; 20/6/22: Stat Rep: RP-221151->RP-221072; Rapporteur: Nokia->Johannes Hejselbaek, Nokia; Rap eMail: ->johannes.hejselbaek@nokia.com;
- 1825: 25/9/20: WID:RP-201372->RP-201477; 6/1/21: WID:RP-201477->RP-202292; 7/4/21: WID:RP-202292->RP-210202; 2/7/21: WID:RP-210202->RP-211043; 29/9/21: WID:RP-211043->RP-211750; 6/1/22: WID:RP-211750->RP-212876; 5/4/22: WID:RP-212876->RP-220302; 12/7/22: WID:RP-220302->RP-221182
- 1826: 13/9/21: Compl:0%->80%13/9/21: CD:Wed 15/09/21->Tue 22/03/2213/9/21: Stat Rep: ->RP-211751; 20/6/22: Rapporteur: LG Electronics->Sang-Wook Lee, LG Electronics; Rap eMail: ->sangwook1.lee@lge.com;
- 1827: 13/9/21: Compl:0%->80%13/9/21: CD:Wed 15/09/21->Tue 22/03/2213/9/21: Stat Rep: ->RP-211751; 20/6/22: Rapporteur: LG Electronics->Sang-Wook Lee, LG Electronics; Rap eMail: ->sangwook1.lee@lge.com;
- 1828: 25/9/20: WID:RP-201373->RP-201710; 6/1/21: WID:RP-201710->RP-202192; 7/4/21: WID:RP-202192->RP-210344; 2/7/21: WID:RP-210344->RP-211054; 29/9/21: WID:RP-211054->RP-211803; 6/1/22: WID:RP-211803->RP-212883; 5/4/22: WID:RP-212883->RP-220202; 12/7/22: WID:RP-220202->RP-221232
- 1829: ; 6/6/22: Compl:0%->100% ; 20/6/22: Rapporteur: ZTE->Wubin Zhou, ZTE; Rap eMail: ->zhou.wubin@zte.com.cn;
- 1830: ; 6/6/22: Compl:0%->100% ; 20/6/22: Rapporteur: ZTE->Wubin Zhou, ZTE; Rap eMail: ->zhou.wubin@zte.com.cn;
- 1831: 25/9/20: WID:RP-200715->RP-201712; 6/1/21: WID:RP-201712->RP-202194; 7/4/21: WID:RP-202194->RP-210346; 2/7/21: WID:RP-210346->RP-211056; 29/9/21: WID:RP-211056->RP-211805; 6/1/22: WID:RP-211805->RP-212885; 5/4/22: WID:RP-212885->RP-220205; 12/7/22: WID:RP-220205->RP-221235
- 1832: 6/6/22: Compl:0%->100%; ; 20/6/22: Rapporteur: ZTE->Wubin Zhou, ZTE; Rap eMail: ->zhou.wubin@zte.com.cn;
- 1833: 6/6/22: Compl:0%->100%; ; 20/6/22: Rapporteur: ZTE->Wubin Zhou, ZTE; Rap eMail: ->zhou.wubin@zte.com.cn;
- 1834: 25/9/20: WID:RP-201026->RP-201726; 6/1/21: WID:RP-201726->RP-202611; 7/4/21: WID:RP-202611->RP-210563; 2/7/21: WID:RP-210563->RP-211375; 29/9/21: WID:RP-211375->RP-212178; 6/1/22: WID:RP-212178->RP-213131; 5/4/22: WID:RP-213131->RP-220695; 12/7/22: WID:RP-220695->RP-221512
- 1835: ; 13/9/21: Compl:0%->60%; ; 22/3/22: Compl:60%->80%; 20/6/22: Rapporteur: Huawei->Zhang, Peng, Huawei; Rap eMail: ->zhangpeng169@huawei.com;
- 1836: ; 13/9/21: Compl:0%->60%; ; 22/3/22: Compl:60%->80%; 20/6/22: Rapporteur: Huawei->Zhang, Peng, Huawei; Rap eMail: ->zhangpeng169@huawei.com;
- 1837: tested: REL-17 basket WIs: NR_CA_R17_Intra, NR_CADC_R17_2BDL_xBUL, NR_CA_R17_3BDL_1BUL, NR_CADC_R17_3BDL_2BUL, NR_CA_R17_4BDL_1BUL, NR_CADC_R17_4BDL_2BUL, NR_CADC_R17_5BDL_xBUL, NR_SUL_combos_R17, DC_R17_1BLTE_1BNR_2DL2UL, DC_R17_2BLTE_1BNR_3DL2UL, DC_...; 14/3/24: FCD:11/12/2024->12/12/2024; Stat Rep: RP-233759->RP-240277;
- 1839: FDD: UL: 874.4-880MHz, DL: 919.4-925MHz ; 2/7/21: WID:RP-210878->RP-211495; 12/7/22: WID:RP-211495->RP-221768
- 1840: FDD: UL: 874.4-880MHz, DL: 919.4-925MHz ; 1/10/21: 38.853 added;; 22/3/22: Compl:0 20/6/22: FCD:22/03/2023->22/09/2022; Compl:100%->95%; Stat Rep: RP-221071->RP-221071/1071/1808/1816; Rapporteur: Union Internationale Chemins de Fer (UIC)->Ingo Wen...
- 1841: ; 22/3/22: Compl:0%->90% ; 20/6/22: FCD:22/03/2023->22/06/2022; Stat Rep: RP-221071->RP-221071/1071/1808/1816; Rapporteur: Union Internationale Chemins de Fer (UIC)->Ingo Wendler, UIC; Rap eMail: ->ingo dot wendler at sbb dot ch;

| ID | WBS | Task | Duration | Start | Finish | Complete | Remaining | Actual finish | Total slack | Constraint | Resources | Work | Actual work | Acronym | PCG approved | Release | TSG approved | Impacted TSs and TRs | Status Report |
| --- | --- | --- | --- | --- | --- | --- | --- | --- | --- | --- | --- | --- | --- | --- | --- | --- | --- | --- | --- |
| 1842 | 817 | **Introduction of 1900MHz NR TDD band for Europe for Rail Mobile Radio (RMR)** | 262d | 2021-03-12 A | 2022-03-11 A | 100% |  |  |  |  |  | 4176h | 4176h | NR_RAIL_EU_1900MHz_TDD | 46 | Rel-17 | 91 |  |  |
| 1843 | 817.1 | Core part: NR_RAIL_EU_1900MHz_TDD | 261d | 2021-03-12 A | 2022-03-11 A | 100% |  |  |  | finish no earlier than 2022-03-12 | R4 | 2088h | 2088h | NR_RAIL_EU_1900MHz_TDD-Core | 46 | Rel-17 | 91 | 38.852 | RP-220148 |
| 1844 | 817.2 | Perf. part: NR_RAIL_EU_1900MHz_TDD | 261d | 2021-03-12 A | 2022-03-11 A | 100% |  |  |  | finish no earlier than 2022-03-12 | R4 | 2088h | 2088h | NR_RAIL_EU_1900MHz_TDD-Perf | 46 | Rel-17 | 91 |  | RP-220148 |
| 1845 | 818 | **Extending current NR operation to 71GHz** | 841d | 2019-12-16 A | 2023-03-03 | 99% | 0d |  | 0d |  | R1 | 19248h | 13280.4h | NR_ext_to_71GHz | 44 | Rel-17 | 86 |  |  |
| 1846 | 818.1 | Core part: Extending current NR operation to 71GHz | 724d | 2019-12-16 A | 2022-09-22 A | 100% |  |  |  | finish no earlier than 2022-09-22 | R1 | 5792h | 5792h | NR_ext_to_71GHz-Core | 44 | Rel-17 | 86 |  | RP-222655 |
| 1847 | 818.2 | Perf. part: Extending current NR operation to 71GHz | 841d | 2019-12-16 A | 2023-03-03 A | 100% |  |  |  | finish no earlier than 2023-03-03 | R1 | 6728h | 6728h | NR_ext_to_71GHz-Perf | 44 | Rel-17 | 86 |  | RP-230662 |
| 1848 | 819 | Study on supporting NR from 52.6 GHz to 71 GHz | 131d | 2019-12-16 A | 2020-06-15 A | 100% |  |  |  | finish no earlier than 2020-06-15 | R1 | 1048h | 1048h | FS_NR_52_to_71GHz | 44 | Rel-17 | 86 |  |  |
| 1849 | 820 | Study on IMT parameters for 6.425-7.025GHz, 7.025-7.125GHz and 10.0-10.5GHz | 190d | 2020-03-25 A | 2020-12-15 A | 100% |  |  |  | finish no earlier than 2020-12-15 | R4 | 1520h | 1520h | FS_NR_IMT_param | 44 | Rel-17 | 87 |  |  |
| 1850 | 821 | **Introduction of NR band n13** | 125d | 2020-03-25 A | 2020-09-15 A | 100% |  |  |  |  | R4 | 3000h | 3000h | NR_n13 | 44 | Rel-17 | 87 |  |  |
| 1851 | 821.1 | Core part: Introduction of NR band n13 | 125d | 2020-03-25 A | 2020-09-15 A | 100% |  |  |  | finish no earlier than 2020-09-15 | R4 | 1000h | 1000h | NR_n13-Core | 44 | Rel-17 | 87 |  |  |
| 1852 | 821.2 | Perf. part: Introduction of NR band n13 | 125d | 2020-03-25 A | 2020-09-15 A | 100% |  |  |  | finish no earlier than 2020-09-15 | R4 | 1000h | 1000h | NR_n13-Perf | 44 | Rel-17 | 87 |  |  |
| 1853 | 822 | **Introduction of NR 47GHz band** | 0d | 2019-03-07 A | 2019-03-07 | 100% |  | 2021-03-19 |  |  | R4 | 4192h | 4192h | NR_47GHz_band | 45 | Rel-17 | 88 |  | RP-211772 |
| 1854 | 822.1 | Core part: Introduction of NR 47GHz band | 262d | 2020-03-19 A | 2021-03-19 A | 100% |  |  |  | finish no earlier than 2021-03-19 | R4 | 2096h | 2096h | NR_47GHz_band-Core | 45 | Rel-17 | 88 |  |  |
| 1855 | 822.2 | Perf. part: Introduction of NR 47GHz band | 262d | 2020-03-19 A | 2021-03-19 A | 100% |  |  |  | finish no earlier than 2021-03-19 | R4 | 2096h | 2096h | NR_47GHz_band-Perf | 45 | Rel-17 | 88 |  |  |
| 1856 | 823 | **Introduction of NR band 24** | 262d | 2020-03-19 A | 2021-03-19 A | 100% |  |  |  |  | R4 | 6288h | 6288h | NR_band_n24 | 45 | Rel-17 | 88 |  |  |
| 1857 | 823.1 | Core part: Introduction of NR band 24 | 262d | 2020-03-19 A | 2021-03-19 A | 100% |  |  |  | finish no earlier than 2021-03-19 | R4 | 2096h | 2096h | NR_band_n24-Core | 45 | Rel-17 | 88 |  |  |
| 1858 | 823.2 | Perf. part: Introduction of NR band 24 | 262d | 2020-03-19 A | 2021-03-19 A | 100% |  |  |  | finish no earlier than 2021-03-19 | R4 | 2096h | 2096h | NR_band_n24-Perf | 45 | Rel-17 | 88 |  |  |
| 1859 | 824 | **Introduction of 6GHz NR licensed bands** | 527d | 2020-09-17 A | 2022-09-22 A | 100% |  |  |  |  | R4 | 12096h | 12096h | NR_6GHz | 45 | Rel-17 | 89 |  |  |
| 1860 | 824.1 | Core part: Introduction of 6GHz NR licensed bands | 460d | 2020-09-17 A | 2022-06-22 A | 100% |  |  |  | finish no earlier than 2022-06-22 | R4 | 3680h | 3680h | NR_6GHz-Core | 45 | Rel-17 | 89 |  | RP-221503 |
| 1861 | 824.2 | Perf. part: Introduction of 6GHz NR licensed bands | 526d | 2020-09-17 A | 2022-09-22 A | 100% |  |  |  | finish no earlier than 2022-09-22 | R4 | 4208h | 4208h | NR_6GHz-Perf | 45 | Rel-17 | 89 |  | RP-221503 |
| 1862 | 825 | **Introduction of operation in full unlicensed band 5925-7125MHz for NR** | 263d | 2021-06-15 A | 2022-06-15 | 43% | 148.82d |  | 972d |  | R4 | 5800h | 2517.93h | NR_6GHz_unlic_full | 47 | Rel-17 | 92 |  |  |
| 1863 | 825.1 | Core part: Introduction of operation in full unlicensed band 5925-7125MHz for NR | 201d | 2021-06-15 A | 2022-03-22 A | 100% |  |  |  | finish no earlier than 2022-03-22 | R4 | 1608h | 1608h | NR_6GHz_unlic_full-Core | 47 | Rel-17 | 92 |  | RP-220450 |
| 1864 | 825.2 | Perf. part: Introduction of operation in full unlicensed band 5925-7125MHz for NR | 262d | 2021-06-16 | 2022-06-15 |  |  |  | 972d | finish no earlier than 2022-06-15 | R4 | 2096h |  | NR_6GHz_unlic_full-Perf | 47 | Rel-17 | 92 |  |  |
| 1865 | 826 | **Introduction of lower 6GHz NR unlicensed operation for Europe** | 388d | 2020-09-17 A | 2022-03-11 A | 100% |  |  |  |  | R4 | 9288h | 9288h | NR_6GHz_unlic_EU | 45 | Rel-17 | 89 |  |  |
| 1866 | 826.1 | Core part: Introduction of lower 6GHz NR unlicensed operation for Europe | 387d | 2020-09-17 A | 2022-03-11 A | 100% |  |  |  | finish no earlier than 2022-03-12 | R4 | 3096h | 3096h | NR_6GHz_unlic_EU-Core | 45 | Rel-17 | 89 | 38.849 | RP-220325 |
| 1867 | 826.2 | Perf. part: Introduction of lower 6GHz NR unlicensed operation for Europe | 387d | 2020-09-17 A | 2022-03-11 A | 100% |  |  |  | finish no earlier than 2022-03-12 | R4 | 3096h | 3096h | NR_6GHz_unlic_EU-Perf | 45 | Rel-17 | 89 |  | RP-220325 |

Notes:
- 1842: TDD: UL: 1900-1910MHz, DL: 1900 MHz 1910 MHz ; 2/7/21: WID:RP-210879->RP-211542 / WI rapporteur name: Union Internationale Chemins de Fer (UIC)
- 1843: TDD: UL: 1900-1910MHz, DL: 1900 MHz 1910 MHz ; 1/10/21: 38.852 added ; / WI rapporteur name: Union Internationale Chemins de Fer (UIC)
- 1844: ; / WI rapporteur name: Union Internationale Chemins de Fer (UIC)
- 1845: affects: NR.; 25/9/20: WID:RP-193229->RP-201845; 6/1/21: WID:RP-201845->RP-202925; 7/4/21: WID:RP-202925->RP-210862; 2/7/21: WID:RP-210862->RP-211584; 29/9/21: WID:RP-211584->RP-212637; 6/1/22: WID:RP-212637->RP-213540; 23/9/22: WID:RP-213540->RP-222656 / WI rapporteur name: Qualcomm
- 1846: affects: NR.; 13/9/21: Compl:0%->45%; ; 22/3/22: Compl:45%->90%; 20/6/22: Stat Rep: RP-221349->RP-221349 / 1749; Rapporteur: Qualcomm->Jing Sun (RAN1); Aida Vera Lopez (RAN4), Qualcomm; Intel Corporation; Rap eMail: ->jingsun@qti.qualcomm.com; ...; 23/9/22: 100%->100 / WI rapporteur name: Jing Sun (RAN1); Aida Vera Lopez (RAN4), Qualcomm; Intel Corporation / WI rapporteur e-mail: jingsun@qti.qualcomm.com; aida.l.vera.lopez@intel.com
- 1847: affects: NR.; 13/9/21: CD:Wed 15/09/21->Wed 22/06/22; ; 22/3/22: Compl:0%->25%; 22/3/22: 6/6/22: CD:12/09/2022->22/12/2022 ; 20/6/22: WG: R4->R1; Stat Rep: RP-221349->RP-221349 / 1749; Rapporteur: Qualcomm->Jing Sun (RAN1); Aida Vera Lopez (RAN4), ...; 17/3/23: FCD:28/02/2023->03/03/2023; Compl:85%->100%; Stat Rep: RP-223126->RP-230662; Rapporteur: Jing Sun (RAN1); Aida Vera Lopez (RAN4), Qualcomm; Intel Corporation->Jing Sun (RAN1); Aida Vera Lopez (RAN4), Qualcomm Incorporated; Intel Corporation; / WI rapporteur name: Jing Sun (RAN1); Aida Vera Lopez (RAN4), Qualcomm Incorporated; Intel Corporation / WI rapporteur e-mail: jingsun@qti.qualcomm.com; aida.l.vera.lopez@intel.com
- 1848: affects: NR. TR 38.8xx; 28/7/20: WID:RP-193259->RP-200902; 25/9/20: WID:RP-200902->RP-201838; 7/4/21: 0%->100 / WI rapporteur name: Intel
- 1849: affects: NR. TR 38.8xx; 6/1/21: WID:RP-200513->RP-202276; 7/4/21: 0%->100 / WI rapporteur name: Ericsson
- 1850: affects: NR. TR 38.8xx / WI rapporteur name: Huawei
- 1851: affects: NR. TR 38.8xx; 6/1/21: 0%->100 / WI rapporteur name: Huawei
- 1852: affects: NR. TR 38.8xx; 6/1/21: 0%->100 / WI rapporteur name: Huawei
- 1853: 7/4/21: WID:RP-201232->RP-210827; 2/7/21: WID:RP-210827->RP-211568; 13/9/21: C / WI rapporteur name: Ericsson
- 1854: 2/7/21: 0%->100; 29/9/21: WID:RP-211568->RP-212528 / WI rapporteur name: Ericsson
- 1855: 29/9/21: 100%->100 / WI rapporteur name: Ericsson
- 1856: 2/7/21: WID:RP-201357->RP-211505 / WI rapporteur name: Ligado Networks
- 1857: 2/7/21: 0%->100 / WI rapporteur name: Ligado Networks
- 1858: 7/4/21: 0%->100 / WI rapporteur name: Ligado Networks
- 1859: missing target dates to be updated ; 6/1/21: WID:RP-202114->RP-202844; 6/1/22: WID:RP-202844->RP-213696; 5/4/22: WID:RP-213696->RP-220686; 12/7/22: WID:RP-220686->RP-221504 / WI rapporteur name: Huawei
- 1860: missing target dates to be updated ; 13/9/21: CD:Tue 15/03/22->Tue 22/03/22 ; 22/3/22: Compl:0%->35% ; 20/6/22: Rapporteur: Huawei->Liehai Liu, Dominique Everaere, Iwajlo Angelow, Fei Xue, Huawei, Ericsson, Nokia, ZTE Corporation; Rap eMail: ->l... / WI rapporteur name: Liehai Liu, Dominique Everaere, Iwajlo Angelow, Fei Xue, Huawei, Ericsson, Nokia, ZTE Corporation / WI rapporteur e-mail: liuliehai@huawei.com, dominique.everaere@ericsson.com, iwajlo.angelow@nokia.com, xue.fei25@zte.com.cn
- 1861: missing target dates to be updated ; 13/9/21: CD:Fri 17/06/22->Wed 22/06/22 ; 22/3/22: Compl:0%->20%; 2 20/6/22: Rapporteur: Huawei->Liehai Liu, Dominique Everaere, Iwajlo Angelow, Fei Xue, Huawei, Ericsson, Nokia, ZTE Corporation; Rap eMail: ->... / WI rapporteur name: Liehai Liu, Dominique Everaere, Iwajlo Angelow, Fei Xue, Huawei, Ericsson, Nokia, ZTE Corporation / WI rapporteur e-mail: liuliehai@huawei.com, dominique.everaere@ericsson.com, iwajlo.angelow@nokia.com, xue.fei25@zte.com.cn
- 1862: in contrast to NR_6GHz_unlic_EU this WI targets Region 2 (Canada, Brazil, Peru, Chile) and Region 3 (South Korea); TR 38.8xx ; 29/9/21: WID:RP-211602->RP-212302; 6/1/22: WID:RP-212302->RP-213683 / WI rapporteur name: Apple
- 1863: in contrast to NR_6GHz_unlic_EU this WI targets Region 2 (Canada, Brazil, Peru, Chile) and Region 3 (South Korea); TR 38.8xx ; 20/6/22: FCD:15/03/2022->22/03/2022; Compl:0%->100%; WID: RP-213683->RP-212683; Stat Rep: ->RP-220450; Rapporteur: Apple->Alexander Sayenko; Rap eMail: ->asayenko@apple.com; / WI rapporteur name: Alexander Sayenko / WI rapporteur e-mail: asayenko@apple.com
- 1864: WI rapporteur name: Apple
- 1865: missing target dates to be updated ; 6/1/21: WID:RP-202116->RP-202592; 7/4/21: WID:RP-202592->RP-210762; 29/9/21: WID:RP-210762->RP-212625; 6/1/22: WID:RP-212625->RP-213604 / WI rapporteur name: Nokia
- 1866: missing target dates to be updated ; 10/2/21: 38.849 added;; 13/9/21: Compl:0%->30%; 13/9/21: CD:Tue 15/03/22->Tue 21/12/21; 13/9/21: Stat Rep: ->RP-211822; / WI rapporteur name: Nokia
- 1867: missing target dates to be updated ; 13/9/21: Compl:0%->15%; 13/9/21: CD:Fri 17/06/22->Tue 21/12/21; 13/9/21: Stat Rep: ->RP-211822; / WI rapporteur name: Nokia

| ID | WBS | Task | Type | Duration | Start | Finish | Complete | Remaining | Total slack | Constraint | Resources | Work | Actual work | Acronym | PCG approved | WI rapporteur name | Release | TSG approved | WI rapporteur e-mail | Status Report | Impacted TSs and TRs |
| --- | --- | --- | --- | --- | --- | --- | --- | --- | --- | --- | --- | --- | --- | --- | --- | --- | --- | --- | --- | --- | --- |
| 1868 | 827 | **Introduction of NR band n67** |  | 130d | 2020-12-14 A | 2021-06-11 A | 100% |  |  |  | R4 | 3120h | 3120h | NR_n67 | 46 | Ericsson | Rel-17 | 90 |  |  |  |
| 1869 | 827.1 | Core part: Introduction of NR band n67 |  | 130d | 2020-12-14 A | 2021-06-11 A | 100% |  |  | finish no earlier than 2021-06-12 | R4 | 1040h | 1040h | NR_n67-Core | 46 | Ericsson | Rel-17 | 90 |  |  |  |
| 1870 | 827.2 | Perf. Part: Introduction of NR band n67 |  | 130d | 2020-12-14 A | 2021-06-11 A | 100% |  |  | finish no earlier than 2021-06-12 | R4 | 1040h | 1040h | NR_n67-Perf | 46 | Ericsson | Rel-17 | 90 |  |  |  |
| 1871 | 828 | **Introduction of NR band n85** |  | 130d | 2020-12-14 A | 2021-06-11 A | 100% |  |  |  | R4 | 3120h | 3120h | NR_n85 | 46 | Ericsson | Rel-17 | 90 |  |  |  |
| 1872 | 828.1 | Core part: Introduction of NR band n85 |  | 130d | 2020-12-14 A | 2021-06-11 A | 100% |  |  | finish no earlier than 2021-06-12 | R4 | 1040h | 1040h | NR_n85-Core | 46 | Ericsson | Rel-17 | 90 |  |  |  |
| 1873 | 828.2 | Perf. part: Introduction of NR band n85 |  | 130d | 2020-12-14 A | 2021-06-11 A | 100% |  |  | finish no earlier than 2021-06-12 | R4 | 1040h | 1040h | NR_n85-Perf | 46 | Ericsson | Rel-17 | 90 |  |  |  |
| 1874 | 829 | **Introduction of 1.6 GHz NR supplemental uplink (SUL) band with same uplink frequency range of Band 24** |  | 262d | 2020-03-19 A | 2021-03-19 A | 100% |  |  |  |  | 4192h | 4192h | NR_SUL_UL_n24 | 45 | Ligado Networks | Rel-17 | 88 |  |  |  |
| 1875 | 829.1 | Core part: NR_SUL_UL_n24 |  | 262d | 2020-03-19 A | 2021-03-19 A | 100% |  |  | finish no earlier than 2021-03-19 | R4 | 2096h | 2096h | NR_SUL_UL_n24-Core | 45 | Ligado Networks | Rel-17 | 88 |  |  |  |
| 1876 | 829.2 | Perf. part: NR_SUL_UL_n24 |  | 262d | 2020-03-19 A | 2021-03-19 A | 100% |  |  | finish no earlier than 2021-03-19 | R4 | 2096h | 2096h | NR_SUL_UL_n24-Perf | 45 | Ligado Networks | Rel-17 | 88 |  |  |  |
| 1877 | 830 | **Introduction of NR supplemental uplink (SUL) band 1880-1920MHz** |  | 127d | 2020-06-22 A | 2020-12-15 A | 100% |  |  |  |  | 2032h | 2032h | NR_SUL_band_1880_1920MHz | 45 | CMCC | Rel-17 | 88 |  |  |  |
| 1878 | 830.1 | Core part: NR_SUL_band_1880_1920MHz |  | 127d | 2020-06-22 A | 2020-12-15 A | 100% |  |  | start no earlier than 2020-06-22 | R4 | 1016h | 1016h | NR_SUL_band_1880_1920MHz-Core | 45 | CMCC | Rel-17 | 88 |  |  |  |
| 1879 | 830.2 | Perf. part: NR_SUL_band_1880_1920MHz |  | 127d | 2020-06-22 A | 2020-12-15 A | 100% |  |  | start no earlier than 2020-06-22 | R4 | 1016h | 1016h | NR_SUL_band_1880_1920MHz-Perf | 45 | CMCC | Rel-17 | 88 |  |  |  |
| 1880 | 831 | **Introduction of NR supplemental uplink (SUL) band 2300-2400MHz** |  | 127d | 2020-06-22 A | 2020-12-15 A | 100% |  |  |  |  | 2032h | 2032h | NR_SUL_band_2300_2400MHz | 45 | CMCC | Rel-17 | 88 |  |  |  |
| 1881 | 831.1 | Core part: NR_SUL_band_2300_2400MHz |  | 127d | 2020-06-22 A | 2020-12-15 A | 100% |  |  | start no earlier than 2020-06-22 | R4 | 1016h | 1016h | NR_SUL_band_2300_2400MHz-Core | 45 | CMCC | Rel-17 | 88 |  |  |  |
| 1882 | 831.2 | Perf. part: NR_SUL_band_2300_2400MHz |  | 127d | 2020-06-22 A | 2020-12-15 A | 100% |  |  | start no earlier than 2020-06-22 | R4 | 1016h | 1016h | NR_SUL_band_2300_2400MHz-Perf | 45 | CMCC | Rel-17 | 88 |  |  |  |
| 1883 | 832 | UE Conformance - New Rel-17 NR licensed bands and extension of existing NR bands |  | 514d | 2020-12-14 A | 2022-12-01 A | 100% |  |  | finish no earlier than 2022-12-01 | R5 | 4112h | 4112h | NR_lic_bands_BW_R17-UEConTest | 46 | Yuxin Hao, Huawei Technologies. Co., Ltd | Rel-17 | 90 | haoyuxin@huawei.com | RP-223215 |  |
| 1884 | 833 | Rel-17 LTE new/modified bands | milestone, manual | 0d | 2016-06-09 A | 2016-06-09 A | 100% |  |  |  |  |  |  |  |  |  | Rel-17 |  |  |  | 26.234; 26.247 |
| 1885 | 834 | **New bands and bandwidth allocation for 5G terrestrial broadcast - part 1** |  | 319d | 2021-01-01 A | 2022-03-22 | 82% | 57.18d | 1033d |  | R1; R2; R3 | 15264h | 12523.7h | LTE_terr_bcast_bands_part1 | 46 | EBU | Rel-17 | 91 |  |  |  |
| 1886 | 834.1 | Core part: New bands and bandwidth allocation for 5G terrestrial broadcast - part 1 |  | 318d | 2021-01-01 A | 2022-03-22 | 97% | 57d | 1033d | finish no earlier than 2022-03-22 | R1; R2; R3 | 7632h | 6264h | LTE_terr_bcast_bands_part1-Core | 46 | EBU | Rel-17 | 91 |  | RP-220172 |  |
| 1887 | 835 | **Additional LTE bands for UE categories M1/M2/NB1/NB2** |  | 534d | 2020-06-08 A | 2022-06-22 A | 100% |  |  |  |  | 8528h | 8528h | LTE_bands_R17_M1_M2_NB1_NB2 | 45 | Ericsson | Rel-17 | 88 |  |  |  |
| 1888 | 835.1 | Core part: LTE_bands_R17_M1_M2_NB1_NB2 |  | 533d | 2020-06-08 A | 2022-06-22 A | 100% |  |  | finish no earlier than 2022-06-22 | R4 | 4264h | 4264h | LTE_bands_R17_M1_M2_NB1_NB2-Core | 45 | Chunhui Zhang, Ericsson | Rel-17 | 88 | Chunhui.Zhang@ericsson.com | RP-221173 |  |
| 1889 | 835.2 | Perf. part: LTE_bands_R17_M1_M2_NB1_NB2 |  | 533d | 2020-06-08 A | 2022-06-22 A | 100% |  |  | finish no earlier than 2022-06-22 | R4 | 4264h | 4264h | LTE_bands_R17_M1_M2_NB1_NB2-Perf | 45 | Chunhui Zhang, Ericsson | Rel-17 | 88 | Chunhui.Zhang@ericsson.com | RP-221173 |  |
| 1890 | 836 | **Modification of LTE Band 24 Specifications to comply with updated regulatory emission limits** |  | 394d | 2020-06-15 A | 2021-12-15 A | 100% |  |  |  |  | 4256h | 4256h | LTE_B24_mod | 45 | Ligado Networks | Rel-17 | 88 |  |  |  |
| 1891 | 836.1 | Core part: LTE_B24_mod |  | 200d | 2020-06-15 A | 2021-03-19 A | 100% |  |  | start no earlier than 2020-06-15 | R4 | 1600h | 1600h | LTE_B24_mod-Core | 45 | Ligado Networks | Rel-17 | 88 |  |  |  |
| 1892 | 836.2 | Perf. part: LTE_B24_mod |  | 200d | 2020-06-15 A | 2021-03-19 A | 100% |  |  | finish no earlier than 2021-03-19 | R4 | 1600h | 1600h | LTE_B24_mod-Perf | 45 | Ligado Networks | Rel-17 | 88 |  |  |  |
| 1893 | 836.3 | UE Conformance - Modification of LTE Band 24 Specifications to comply with updated regulatory emission limits |  | 132d | 2021-06-15 A | 2021-12-15 A | 100% |  |  | finish no earlier than 2021-12-15 | R5 | 1056h | 1056h | LTE_B24_mod-UEConTest | 47 | Ligado Networks | Rel-17 | 92 |  |  |  |
| 1894 | 837 | Rel-17 LTE inter-band Carrier Aggregation (LTE iterbCA) | milestone, manual | 0d | 2016-06-09 A | 2016-06-09 A | 100% |  |  |  |  |  |  |  |  |  | Rel-17 |  |  |  | 26.234; 26.247 |

Notes:
- 1869: ; 2/7/21: 0%->100
- 1870: ; 2/7/21: 0%->100
- 1871: ; 7/4/21: WID:RP-202830->RP-210707
- 1872: ; 2/7/21: 0%->100
- 1873: ; 2/7/21: 0%->100
- 1874: 7/4/21: WID:RP-201251->RP-210341
- 1875: 7/4/21: 0%->100
- 1876: 7/4/21: 0%->100
- 1878: 6/1/21: 0%->100
- 1879: 6/1/21: 0%->100
- 1881: 6/1/21: 0%->100
- 1882: 6/1/21: 0%->100
- 1883: tested: REL-17 WIs: NR_n13, NR_47GHz_band, NR_band_n24, NR_SUL_UL_n24, NR_SUL_band_1880_1920MHz, NR_SUL_band_2300_2400MHz, NR_bands_R17_BWs, NR_FR1_35MHz_45MHz_BW ; 8/4/21: 0%->16 ; 20/6/22: Rapporteur: Huawei->Yuxin Hao, Huawei Technologies. Co.,...;...; 9/1/23: 100%->100
- 1885: 13/09/21: "-part 1/" added' R4->R1, R2, R3
- 1886: WID will be split into RAN1/2/3 REL-17 WID (part1; target March 22) and a RAN4 REL18 WID (part2; REL-indep. From REL-17; target March 23) at RAN #92e; no Perf. Part; 13/9/21: C ;
- 1887: 25/9/20: WID:RP-200804->RP-201646; 29/9/21: WID:RP-201646->RP-211857; 6/1/22: WID:RP-211857->RP-212906; 5/4/22: WID:RP-212906->RP-220816
- 1888: ; 13/9/21: Compl:0%->70%; 13/9/21: CD:Wed 15/09/21->Tue 21/09/21; 13/9/21: Stat Rep: ->RP-211856 ; 20/6/22: Rapporteur: Ericsson->Chunhui Zhang, Ericsson; Rap eMail: ->Chunhui.Zhang@ericsson.com;
- 1889: ; 13/9/21: Compl:0%->70%; 13/9/21: CD:Wed 15/09/21->Tue 21/09/21; 13/9/21: Stat Rep: ->RP-211856 ; 20/6/22: Rapporteur: Ericsson->Chunhui Zhang, Ericsson; Rap eMail: ->Chunhui.Zhang@ericsson.com;
- 1890: 2/7/21: WID:RP-201356->RP-211507
- 1891: 2/7/21: 0%->100
- 1892: 7/4/21: 0%->100
- 1893: tested: REL-17 WI LTE_B24_mod-Core ; 29/9/21: WID:RP-211396->RP-212497; 6/1/22: 0%->100

| ID | WBS | Task | Type | Duration | Start | Finish | Complete | Remaining | Total slack | Constraint | Resources | Work | Actual work | Acronym | PCG approved | WI rapporteur name | Release | TSG approved | WI rapporteur e-mail | Status Report | TSG stopped | Impacted TSs and TRs |
| --- | --- | --- | --- | --- | --- | --- | --- | --- | --- | --- | --- | --- | --- | --- | --- | --- | --- | --- | --- | --- | --- | --- |
| 1895 | 838 | **LTE iterbCA for 2 bands DL with 1 band UL** |  | 524d | 2020-06-22 A | 2022-06-22 A | 100% |  |  |  |  | 8368h | 8368h | LTE_CA_R17_2BDL_1BUL | 45 | Qualcomm | Rel-17 | 88 |  |  |  |  |
| 1896 | 838.1 | Core part: LTE_CA_R17_2BDL_1BUL |  | 523d | 2020-06-22 A | 2022-06-22 A | 100% |  |  | finish no earlier than 2022-06-22 | R4 | 4184h | 4184h | LTE_CA_R17_2BDL_1BUL-Core | 45 | Bin Han, Qualcomm Incorporated | Rel-17 | 88 | binhan@qti.qualcomm.com | RP-221388 |  |  |
| 1897 | 838.2 | Perf. part: LTE_CA_R17_2BDL_1BUL |  | 523d | 2020-06-22 A | 2022-06-22 A | 100% |  |  | finish no earlier than 2022-06-22 | R4 | 4184h | 4184h | LTE_CA_R17_2BDL_1BUL-Perf | 45 | Bin Han, Qualcomm Incorporated | Rel-17 | 88 | binhan@qti.qualcomm.com | RP-221388 |  |  |
| 1898 | 839 | **LTE iterbCA for 3 bands DL with 1 band UL** |  | 524d | 2020-06-22 A | 2022-06-22 A | 100% |  |  |  |  | 8368h | 8368h | LTE_CA_R17_3BDL_1BUL | 45 | Huawei | Rel-17 | 88 |  |  |  |  |
| 1899 | 839.1 | Core part: LTE_CA_R17_3BDL_1BUL |  | 523d | 2020-06-22 A | 2022-06-22 A | 100% |  |  | finish no earlier than 2022-06-22 | R4 | 4184h | 4184h | LTE_CA_R17_3BDL_1BUL-Core | 45 | Mohammad Abdi Abyaneh, Huawei, HiSilicon | Rel-17 | 88 | mohammad.abdi.abyaneh@huawei.com | RP-221525 |  |  |
| 1900 | 839.2 | Stopped - Perf. part: LTE iterbCA for 3 bands DL with 1 band UL |  | 523d | 2020-06-22 A | 2022-06-22 A | 100% |  |  | finish no earlier than 2022-06-22 | R4 | 4184h | 4184h | LTE_CA_R17_3BDL_1BUL-Perf | 45 | Mohammad Abdi Abyaneh, Huawei, HiSilicon | Rel-17 | 88 | mohammad.abdi.abyaneh@huawei.com | RP-221525 | 96 |  |
| 1901 | 840 | **LTE iterbCA Core for x bands DL (x=4, 5, 6) with 1 band UL** |  | 524d | 2020-06-22 A | 2022-06-22 A | 100% |  |  |  |  | 8368h | 8368h | LTE_CA_R17_xBDL_1BUL | 45 | Nokia | Rel-17 | 88 |  |  |  |  |
| 1902 | 840.1 | Core part: LTE_CA_R17_xBDL_1BUL |  | 523d | 2020-06-22 A | 2022-06-22 A | 100% |  |  | finish no earlier than 2022-06-22 | R4 | 4184h | 4184h | LTE_CA_R17_xBDL_1BUL-Core | 45 | Iwajlo ANGELOW, Nokia | Rel-17 | 88 | iwajlo.angelow@nokia.com | RP-221306 |  |  |
| 1903 | 840.2 | Perf. part: LTE_CA_R17_xBDL_1BUL |  | 523d | 2020-06-22 A | 2022-06-22 A | 100% |  |  | finish no earlier than 2022-06-22 | R4 | 4184h | 4184h | LTE_CA_R17_xBDL_1BUL-Perf | 45 | Iwajlo ANGELOW, Nokia | Rel-17 | 88 | iwajlo.angelow@nokia.com | RP-221306 |  |  |
| 1904 | 841 | **LTE iterbCA for 2 bands DL with 2 bands UL** |  | 524d | 2020-06-22 A | 2022-06-22 A | 100% |  |  |  |  | 8368h | 8368h | LTE_CA_R17_2BDL_2BUL | 45 | Huawei | Rel-17 | 88 |  |  |  |  |
| 1905 | 841.1 | Core part: LTE_CA_R17_2BDL_2BUL |  | 523d | 2020-06-22 A | 2022-06-22 A | 100% |  |  | finish no earlier than 2022-06-22 | R4 | 4184h | 4184h | LTE_CA_R17_2BDL_2BUL-Core | 45 | Liu Ye, Huawei | Rel-17 | 88 | leo.liuye@huawei.com | RP-221527 |  |  |
| 1906 | 841.2 | Perf. part: LTE_CA_R17_2BDL_2BUL |  | 523d | 2020-06-22 A | 2022-06-22 A | 100% |  |  | finish no earlier than 2022-06-22 | R4 | 4184h | 4184h | LTE_CA_R17_2BDL_2BUL-Perf | 45 | Liu Ye, Huawei | Rel-17 | 88 | leo.liuye@huawei.com | RP-221527 |  |  |
| 1907 | 842 | **LTE iterbCA for x bands DL (x= 3, 4, 5) with 2 bands UL** |  | 524d | 2020-06-22 A | 2022-06-22 A | 100% |  |  |  |  | 8368h | 8368h | LTE_CA_R17_xBDL_2BUL | 45 | LG | Rel-17 | 88 |  |  |  |  |
| 1908 | 842.1 | Core part: LTE_CA_R17_xBDL_2BUL |  | 523d | 2020-06-22 A | 2022-06-22 A | 100% |  |  | finish no earlier than 2022-06-22 | R4 | 4184h | 4184h | LTE_CA_R17_xBDL_2BUL-Core | 45 | Jin Woong Park, LG Electronics | Rel-17 | 88 | jinwoong.park@lge.com | RP- 221189 |  |  |
| 1909 | 842.2 | Perf. part: LTE_CA_R17_xBDL_2BUL |  | 523d | 2020-06-22 A | 2022-06-22 A | 100% |  |  | finish no earlier than 2022-06-22 | R4 | 4184h | 4184h | LTE_CA_R17_xBDL_2BUL-Perf | 45 | Jin Woong Park, LG Electronics | Rel-17 | 88 | jinwoong.park@lge.com | RP- 221189 |  |  |
| 1910 | 843 | UE Conformance - Rel-17 LTE CA Configurations |  | 332d | 2023-09-09 A | 2024-12-12 | 30% | 232.4d | 318d | finish no earlier than 2024-12-12 | R5 | 2656h |  | LTE_CA_R17-UEConTest | 51 | Lei GAO, China Telecom | Rel-17 | 101 | gaol8@chinatelecom.cn | RP-240360 |  |  |
| 1911 | 844 | Release 17 other Studies | milestone | 0d? | 2016-03-15 A | 2016-03-15 A | 100% |  |  | start no earlier than 2016-03-15 |  |  |  |  |  |  | Rel-17 |  |  |  |  |  |
| 1912 | 845 | Study on the security of AMF re-allocation |  | 323d | 2020-09-16 A | 2021-12-10 A | 100% |  |  | finish no earlier than 2021-12-12 | S3 | 2584h | 2584h | FS_AMFREAL_SEC | 45 | Tsiatsis, Vlasios, Ericsson | Rel-17 | 89 | vlasios.tsiatsis@ericsson.com |  |  | 33.864 |
| 1913 | 846 | Study on enhanced Security Aspects of the 5G Service Based Architecture |  | 266d | 2020-12-04 A | 2021-12-10 A | 100% |  |  | finish no earlier than 2021-12-12 | S3 | 2128h | 2128h | FS_eSBA_SEC | 46 | Anja Jerichow, Nokia | Rel-17 | 90 | anja.jerichow@nokia.com |  |  | 33.875 |
| 1914 | 847 | Study on SECAM and SCAS for 3GPP virtualized network products |  | 834d? | 2018-10-02 A | 2021-12-10 A | 100% |  |  | finish no earlier than 2021-12-12 | S3 | 6672h | 6672h | FS_VNP_SECAM_SCAS | 41 | Minpeng Qi, China Mobile | Rel-17 | 81 | qiminpeng@chinamobile.com |  |  | New |
| 1915 | 848 | Study on Long Term Key Update Process (LTKUP) Detailed solutions |  | 326d | 2018-12-13 A | 2020-03-12 A | 100% |  |  | finish no earlier than 2020-03-12 | S3 | 2608h | 2608h | FS_LTKUP_Detail | 42 | Evans, Tim, Vodafone | Rel-17 | 82 | tim.evans1@vodafone.com |  |  |  |
| 1916 | 849 | Study on 5G Glass-type AR/MR Devices |  | 447d | 2020-06-25 A | 2022-03-11 A | 100% |  |  | finish no earlier than 2022-03-12 | S4 | 3576h | 3576h | FS_5GSTAR | 45 | Hakju Ryan Lee | Rel-17 | 88 | hakju00.lee@samsung.com |  |  | 26.998 |
| 1917 | 850 | Study on VR Streaming Conformance and Guidelines |  | 651d | 2019-09-13 A | 2022-03-11 A | 100% |  |  | finish no earlier than 2022-03-12 | S4 | 5208h | 5208h | FS_VR_CoGui | 43 | Igor CURCIO | Rel-17 | 85 | igor.curcio@nokia.com |  |  | New ; 26.999; 26.119 |
| 1918 | 851 | Study on 5G media streaming extensions |  | 331d | 2020-12-04 A | 2022-03-11 A | 100% |  |  | finish no earlier than 2022-03-12 | S4 | 2648h | 2648h | FS_5GMS_EXT | 46 | Iraj Sodagar, Company, Tencent | Rel-17 | 90 | irajs@live.com |  |  | 26.804 |
| 1919 | 852 | Study on Streaming Architecture extensions For Edge processing |  | 318d | 2020-03-25 A | 2021-06-11 A | 100% |  |  | finish no earlier than 2021-06-12 | S4 | 2544h | 2544h | FS_EMSA | 44 | Bouazizi, Imed, Qualcomm | Rel-17 | 87 | bouazizi@qti.qualcomm.com |  |  |  |
| 1920 | 853 | Study on 5G Video Codec Characteristics |  | 578d | 2020-03-25 A | 2022-06-10 A | 100% |  |  | finish no earlier than 2022-06-12 | S4 | 4624h | 4624h | FS_5GVideo | 44 | Thomas Stockhammer | Rel-17 | 87 | tsto@qti.qualcomm.com |  |  |  |
| 1921 | 854 | Study on the use of NBMP in FLUS |  | 381d | 2020-03-25 A | 2021-09-08 A | 100% |  |  | finish no earlier than 2021-09-08 | S4 | 3048h | 3048h | FS_FLUS_NBMP | 44 | Iraj Sodagar | Rel-17 | 87 | irajsodagar@tencent.com |  |  | 26.939 |

Notes:
- 1895: 25/9/20: WID:RP-201248->RP-201754; 6/1/21: WID:RP-201754->RP-202573; 7/4/21: WID:RP-202573->RP-210227; 2/7/21: WID:RP-210227->RP-211560; 29/9/21: WID:RP-211560->RP-211859; 6/1/22: WID:RP-211859->RP-212933; 5/4/22: WID:RP-212933->RP-220552; 12/7/22: WID:RP-220552->RP-221389
- 1896: 20/6/22: FCD:15/09/2021->22/06/2022; Compl:0%->100%; WID: RP-220552->RP-212933; Stat Rep: ->RP-221388; Rapporteur: Qualcomm->Bin Han, Qualcomm Incorporated; Rap eMail: ->binhan@qti.qualcomm.com;
- 1897: ; 6/6/22: Comp ; 20/6/22: Rapporteur: Qualcomm->Bin Han, Qualcomm Incorporated; Rap eMail: ->binhan@qti.qualcomm.com;
- 1898: 25/9/20: WID:RP-201244->RP-201730; 6/1/21: WID:RP-201730->RP-202615; 7/4/21: WID:RP-202615->RP-210540; 2/7/21: WID:RP-210540->RP-211388; 29/9/21: WID:RP-211388->RP-212192; 6/1/22: WID:RP-212192->RP-213144; 5/4/22: WID:RP-213144->RP-220715; 12/7/22: WID:RP-220715->RP-221526
- 1899: ; 22/3/22: Compl:0%->67%; 20/6/22: Rapporteur: Huawei->Mohammad Abdi Abyaneh, Huawei, HiSilicon; Rap eMail: ->mohammad.abdi.abyaneh@huawei.com;
- 1900: 6/1/21: stopped at 0%; 22/3/22: Compl:100%->10%; 22/3/22: CD:15/09/2021->10/06/2022 ; 20/6/22: Rapporteur: Huawei->Mohammad Abdi Abyaneh, Huawei, HiSilicon; Rap eMail: ->mohammad.abdi.abyaneh@huawei.com;
- 1901: 25/9/20: WID:RP-201245->RP-201911; 6/1/21: WID:RP-201911->RP-202212; 7/4/21: WID:RP-202212->RP-210837; 2/7/21: WID:RP-210837->RP-211068; 29/9/21: WID:RP-211068->RP-211885; 6/1/22: WID:RP-211885->RP-212813; 5/4/22: WID:RP-212813->RP-220175; 12/7/22: WID:RP-220175->RP-221305
- 1902: ; 13/9/21: Compl:0%->85%; 13/9/21: CD:Wed 15/09/21->Tue 22/03/22; ; 20/6/22: Rapporteur: Nokia->Iwajlo ANGELOW, Nokia; Rap eMail: ->iwajlo.angelow@nokia.com;
- 1903: ; 13/9/21: Compl:0%->85%; 13/9/21: CD:Wed 15/09/21->Tue 22/03/22; ; 20/6/22: Rapporteur: Nokia->Iwajlo ANGELOW, Nokia; Rap eMail: ->iwajlo.angelow@nokia.com;
- 1904: 25/9/20: WID:RP-201246->RP-201732; 7/4/21: WID:RP-201732->RP-210542; 2/7/21: WID:RP-210542->RP-211390; 29/9/21: WID:RP-211390->RP-212194; 5/4/22: WID:RP-212194->RP-220718; 12/7/22: WID:RP-220718->RP-221528
- 1905: ; 22/3/22: Compl:0%->70%; 20/6/22: Rapporteur: Huawei->Liu Ye, Huawei; Rap eMail: ->leo.liuye@huawei.com;
- 1906: 22/3/22: CD:15/09/2021->12/06/202222/3/22: Stat Rep: ->RP-220716 ; 20/6/22: Rapporteur: Huawei->Liu Ye, Huawei; Rap eMail: ->leo.liuye@huawei.com;
- 1907: 25/9/20: WID:RP-201247->RP-201475; 6/1/21: WID:RP-201475->RP-202289; 7/4/21: WID:RP-202289->RP-210200; 2/7/21: WID:RP-210200->RP-211041; 29/9/21: WID:RP-211041->RP-211748; 6/1/22: WID:RP-211748->RP-212874; 5/4/22: WID:RP-212874->RP-220295; 12/7/22: WID:RP-220295->RP-221188
- 1908: ; 22/3/22: Compl:0%->95%; ; 20/6/22: FCD:11/03/2022->22/06/2022; Compl:95%->100%; Stat Rep: RP-220299->RP- 221189; Rapporteur: LG->Jin Woong Park, LG Electronics; Rap eMail: ->jinwoong.park@lge.com;
- 1909: ; 22/3/22: Compl:0%->95%; ; 20/6/22: FCD:11/03/2022->22/06/2022; Compl:95%->100%; Stat Rep: RP-220299->RP- 221189; Rapporteur: LG->Jin Woong Park, LG Electronics; Rap eMail: ->jinwoong.park@lge.com;
- 1910: 8/12/23: Compl:0%->5%; Stat Rep: ->RP-233566; Rapporteur: China Telecom->Lei GAO, China Telecom; Rap eMail: ->gaol8@chinatelecom.cn; ; 14/3/24: FCD:11/12/2024->12/12/2024; Compl:5%->30%; Stat Rep: RP-233566->RP-240360;
- 1911: -
- 1912: 5/12/20: 0%->30; 19/3/21: 30%->50; 19/3/21: FCD:12/03/2021->09/21; 11/6/21: 50%->70; 11/6/21: FCD:Wed 08/09/->12/21; 13/9/21: 70%->75; 12/3/22: 75%->100
- 1913: 10/2/21: 33.875 added;; 19/3/21: 0%->45; 19/3/21: FCD:11/06/2021->09/21; 11/6/21: 45%->70; 11/6/21: FCD:Wed 08/09/->12/21; 4/6/22: 70%->75; 12/9/22: 75%->87; 31/3/23: 87%->100
- 1914: 2/10/18: Moved from Rel-17¦7/12/18: 0%->5¦20/3/19: 5%->20; 13/9/19: 20%->30; 13/9/19: FCD:13/09/2019->12/20; 6/12/19: 30%->35; 6/12/19: FCD:12/12/2019->03/20; 25/03/20: Rel-16->Rel-17; 26/6/20: FCD:12/03/2020->12/20; 26/6/20: 35%->60; 5/12/20: 60%->70;
- 1915: 20/3/19: 0%->60¦20/3/19: 0%->60; 13/9/19: FCD:19/09/2019->12/20; 6/12/19: FCD:12/12/2019->03/20; 25/03/20: Rel-16->Rel-17; 26/6/20: 60%->100
- 1916: 25/9/20: 26.998 added;; 5/12/20: 0%->10; 21/3/21: 10%->20; 21/3/21: FCD:11/06/2021->09/21; 11/6/21: 20%->65; 11/6/21: FCD:Wed 08/09/->12/21; 13/9/21: 65%->80; 13/12/21: 80%->90; 13/12/21: FCD:Fri 10/12/->03/22; 12/3/22: 90%->100
- 1917: ; 8/10/19: 26.999 added;; 8/10/19: 26.119 added;; 25/3/20: 0%->10; 20/4/20: FCD:12/06/2020->12/20; 5/12/20: FCD:17/12/2020->06/20; 21/3/21: 10%->20; 11/6/21: FCD:Fri 11/06/->12/21; 13/12/21: 20%->90; 13/12/21: FCD:Fri 10/12/->03/22; 12/3/22: 90%->100
- 1918: 21/3/21: 0%->5; 11/6/21: 5%->40; 2/7/21: 26.804 added;; 13/9/21: 40%->50; 13/12/21: 50%->60; 13/12/21: FCD:Wed 08/09/->03/22; 12/3/22: 60%->100
- 1919: 10/6/20: 0%->5; 26/6/20: 5%->15; 5/12/20: 15%->30; 5/12/20: FCD:17/12/2020->06/20; 21/3/21: 30%->60; 11/6/21: 60%->100
- 1920: 10/6/20: 0%->20; 26/6/20: 20%->20; 5/12/20: 20%->45; 5/12/20: FCD:17/12/2020->06/20; 21/3/21: 45%->55; 11/6/21: 55%->70; 11/6/21: FCD:Fri 11/06/->12/21; 13/9/21: 70%->75; 13/12/21: 75%->85; 13/12/21: FCD:Fri 10/12/->03/22; 12/3/22: 85%->90; 12/3/22: FC
- 1921: ; 10/6/20: 0%->10; 5/12/20: 10%->30; 5/12/20: FCD:11/12/2020->09/20; 21/3/21: 30%->40; 11/6/21: 40%->96; 13/9/21: 96%->100

| ID | WBS | Task | Type | Duration | Start | Finish | Complete | Constraint | Resources | Work | Actual work | Acronym | PCG approved | Impacted TSs and TRs | WI rapporteur name | WI rapporteur e-mail | Release | TSG approved | Status Report | TSG stopped |
| --- | --- | --- | --- | --- | --- | --- | --- | --- | --- | --- | --- | --- | --- | --- | --- | --- | --- | --- | --- | --- |
| 1922 | 855 | **Study on enhanced IMS to 5GC Integration Phase 2** |  | 382d | 2020-09-25 A | 2022-03-11 A | 100% |  | ct | 12192h | 12192h | FS_eIMS5G2 | 45 | 23.700-10 | Haitao Wei (Huawei) | weihaitao@huawei.com | Rel-17 | 88 |  |  |
| 1923 | 855.1 | CT1 aspects of FS_eIMS5G2 |  | 381d | 2020-09-25 A | 2022-03-11 A | 100% | finish no earlier than 2022-03-12 | C1 | 3048h | 3048h | FS_eIMS5G2 | 45 | 23.700-10 | Haitao Wei (Huawei) | weihaitao@huawei.com | Rel-17 | 88 |  |  |
| 1924 | 855.2 | CT3 aspects of FS_eIMS5G2 |  | 381d | 2020-09-25 A | 2022-03-11 A | 100% | finish no earlier than 2022-03-12 | C3 | 3048h | 3048h | FS_eIMS5G2 | 45 | 23.700-10 | Haitao Wei (Huawei) | weihaitao@huawei.com | Rel-17 | 88 |  |  |
| 1925 | 855.3 | CT4 aspects of FS_eIMS5G2 |  | 381d | 2020-09-25 A | 2022-03-11 A | 100% | finish no earlier than 2022-03-12 | C4 | 3048h | 3048h | FS_eIMS5G2 | 45 | 23.700-10 | Haitao Wei (Huawei) | weihaitao@huawei.com | Rel-17 | 88 |  |  |
| 1926 | 856 | Study on Port Number Allocation Alternatives for New 3GPP Interfaces |  | 388d | 2020-09-16 A | 2022-03-11 A | 100% | finish no earlier than 2022-03-12 | C4 | 3104h | 3104h | FS_PortAl | 45 |  | Giorgi Gulbani, Huawei | giorgi.gulbani@huawei.com | Rel-17 | 89 |  |  |
| 1927 | 857 | Study on scenarios and requirements of in-coverage, partial coverage, and out-of-coverage NR positioning use cases |  | 323d | 2020-06-22 A | 2021-09-15 A | 100% | finish no earlier than 2021-09-15 | RP | 2584h | 2584h | FS_NR_pos_cov | 45 |  | LG Electronics |  | Rel-17 | 88 |  |  |
| 1928 | 858 | Study on XR (Extended Reality) evaluations for NR |  | 527d | 2019-12-16 A | 2021-12-21 A | 100% | finish no earlier than 2021-12-21 | R1 | 4216h | 4216h | FS_NR_XR_eval | 44 |  | Qualcomm |  | Rel-17 | 86 | RP-212047 |  |
| 1929 | 859 | Study on enhancement of RAN slicing for NR |  | 262d | 2019-12-16 A | 2020-12-15 A | 100% | finish no earlier than 2020-12-15 | R2 | 2096h | 2096h | FS_NR_slice | 44 |  | CMCC |  | Rel-17 | 86 |  |  |
| 1930 | 860 | Study on enhancement for data collection for NR and ENDC |  | 450d | 2020-06-22 A | 2022-03-11 A | 100% | finish no earlier than 2022-03-22 | R3 | 3600h | 3600h | FS_NR_ENDC_data_collect | 45 | 37.817; 38.817 | CMCC |  | Rel-17 | 88 | RP-220634 |  |
| 1931 | 861 | Study on high-power UE operation for fixed-wireless/vehicle-mounted use cases in LTE bands 5 and 12 and NR band n71 |  | 1d | 2020-03-19 A | 2020-03-19 A | 100% | start no earlier than 2020-03-19 | R4 | 8h | 8h | FS_LTE_NR_HPUE_FWVM | 45 | 37.880 | Nokia |  | Rel-17 | 88 |  |  |
| 1932 | 862 | Study on high power UE (power class 2) for one NR FDD band |  | 202d | 2020-12-14 A | 2021-09-21 A | 100% | finish no earlier than 2021-09-21 | R4 | 1616h | 1616h | FS_NR_PC2_UE_FDD | 46 |  | China Unicom |  | Rel-17 | 90 | RP-211854 |  |
| 1933 | 863 | Study on extended 600MHz NR band |  | 193d | 2020-12-14 A | 2021-09-08 A | 100% | finish no earlier than 2021-09-08 | R4 | 1544h | 1544h | FS_NR_600MHz_ext | 46 |  | Spark |  | Rel-17 | 90 |  |  |
| 1934 | 864 | Study on charging aspects of 5GS CIoT |  | 323d | 2020-09-16 A | 2021-12-10 A | 100% | finish no earlier than 2021-12-12 | S5 | 2584h | 2584h | FS_5G_CIoT_CH | 45 |  | Zhu, Lei, Huawei | lei.zhu@huawei.com | Rel-17 | 89 |  |  |
| 1935 | 865 | Stopped - Study on the Usage of User Identifiers in the 5G System |  | 267d | 2019-06-06 A | 2020-06-12 A | 100% | finish no earlier than 2020-06-12 | S2 | 2136h | 2136h | FS_UUI5 | 43 | New ; 23.700-094; | Starsinic, Michael, Convida Wireless LLC | starsinic.michael@convidawireless.com | Rel-17 | 84 |  | 95 |
| 1936 | 866 | Stopped - Study on service-based support for SMS in 5GC |  | 195.88d | 2019-03-07 A | 2019-12-05 A | 100% |  | S2 | 1567h | 1567h | FS_SB_SMS | 42 | New | George Foti | George dot Foti at ericsson dot com | Rel-17 | 83 |  | 95 |
| 1937 | 867 | Stopped - Study on UPF enhancement for control and SBA |  | 261.88d | 2019-03-07 A | 2020-03-06 A | 100% |  | S2 | 2095h | 2095h | FS_UPCAS | 42 | New | Dan Wang, China Mobile | wangdanyjy@chinamobile.com | Rel-17 | 83 |  | 95 |
| 1938 | 868 | Stopped - Study on security aspects of the Disaggregated gNB Architecture |  | 187d | 2020-06-25 A | 2021-03-12 A | 100% | finish no earlier than 2021-03-12 | S3 | 1496h | 1496h | FS_disagg_gNB_Sec | 45 | 33.840 | Sen XU, China Telecom | xusen@chinatelecom.cn | Rel-17 | 88 |  | 95 |
| 1939 | 869 | --- RELEASE 16 --- | milestone | 0d? | 2016-03-15 A | 2016-03-15 A | 100% | start no earlier than 2016-03-15 |  |  |  |  |  |  |  |  | Rel-16 |  |  |  |
| 1940 | 870 | Release 16 Features and related studies | milestone | 0d? | 2016-03-15 A | 2016-03-15 A | 100% | start no earlier than 2016-03-15 |  |  |  |  |  |  |  |  | Rel-16 |  |  |  |
| 1941 | 871 | Enhancement of Ultra-Reliable (UR) Low Latency Communications (URLLC) | milestone | 0d? | 2017-12-15 A | 2017-12-15 A | 100% |  |  |  |  |  |  |  |  |  | Rel-16 |  |  |  |
| 1942 | 872 | **Enhancement of URLLC support in the 5G Core network** |  | 1624d? | 2017-12-15 A | 2024-03-03 A | 100% |  |  | 18544h | 18544h | 5G_URLLC | 42 | 23.501; 23.502; 23.503 | Hui Ni, Huawei | Hui.ni@huawei.com | Rel-16 | 82 |  |  |
| 1943 | 872.1 | Study on enhancement of URLLC supporting in 5GC |  | 197d? | 2018-03-15 A | 2018-12-14 A | 100% | finish no earlier than 2018-12-14 | S2 | 1576h | 1576h | FS_5G_URLLC | 40 | 23.xyz; 23.725 | Hui Ni, Huawei | Hui.ni@huawei.com | Rel-16 | 79 |  |  |
| 1944 | 872.2 | Study on the security of URLLC for 5GS |  | 200d? | 2018-09-06 A | 2019-06-12 A | 100% | finish no earlier than 2019-06-12 | S3 | 1600h | 1600h | FS_5G_URLLC_SEC | 41 | New | Rong Wu, Huawei Technologies | Raina.wu@huawei.com | Rel-16 | 81 |  |  |
| 1945 | 872.3 | Stage 2 of 5G_URLLC |  | 136d | 2018-12-13 A | 2019-06-20 A | 100% | start no earlier than 2018-12-13 | S2 | 1088h | 1088h | 5G_URLLC | 42 | 23.501; 23.502; 23.503 | Hui Ni, Huawei | Hui.ni@huawei.com | Rel-16 | 82 |  |  |
| 1946 | 872.4 | Security of URLLC for 5GS |  | 201d | 2019-06-06 A | 2020-03-12 A | 100% | finish no earlier than 2020-03-12 | S3 | 1608h | 1608h | 5G_URLLC_SEC | 43 | 33.501 | Rong Wu, Huawei Technologies | Raina.wu@huawei.com | Rel-16 | 84 |  |  |

Notes:
- 1922: 13/9/20: 0%->5; 13/9/20: FCD:19/03/2021->09/21; 25/9/20: 23.700-10 added;; 5/12/20: 5%->10; 5/12/20: 10%->70; 21/3/21: 70%->15
- 1923: 13/9/20: 0%->5; 13/9/20: FCD:19/03/2021->09/21; 25/9/20: 23.700-10 added;; 5/12/20: 5%->10; 5/12/20: 10%->70; 21/3/21: 70%->15; 13/9/21: 15%->60; 13/12/21: 60%->90; 12/3/22: FCD:08/09/2021->3/22; 12/3/22: 90%->100
- 1924: 13/9/20: 0%->5; 13/9/20: FCD:19/03/2021->09/21; 25/9/20: 23.700-10 added;; 5/12/20: 5%->10; 5/12/20: 10%->70; 21/3/21: 70%->15; 8/4/21: 15%->30; 11/6/21: 0%->5; 13/9/21: FCD:Wed 08/09/->03/22; 12/3/22: 5%->100
- 1925: 13/9/20: 0%->5; 13/9/20: FCD:19/03/2021->09/21; 25/9/20: 23.700-10 added;; 5/12/20: 5%->10; 5/12/20: 10%->70; 21/3/21: 70%->15; 8/4/21: 15%->30; 11/6/21: 30%->40; 11/6/21: 40%->30; 14/6/21: 30%->40; 13/9/21: 40%->50; 13/9/21: FCD:Wed 08/09/->12/21; 13
- 1926: 13/9/20: FCD:11/06/2021->09/21; 25/9/20: WID:CP-202029->CP-202243; 5/12/20: 0%->30; 21/3/21: 30%->50; 11/6/21: 50%->70; 13/9/21: 70%->85; 13/9/21: FCD:Wed 08/09/->03/22; 13/12/21: 85%->100; 22/3/22: WID:CP-202243->CP-220391
- 1927: 25/9/20: WID:RP-201384->RP-201518; 29/9/21: 0%->100
- 1928: affects: NR.; 28/7/20: WID:RP-193241->RP-201145; 7/4/21: WID:RP-201145->RP-210460; 13/9/21: Compl:0%->70% ; 6/1/22: 70%->100
- 1929: affects: NR. TR 38.8xx; 25/9/20: WID:RP-193254->RP-201612; 2/7/21: 0%->100
- 1930: 25/9/20: WID:RP-201304->RP-201620; 25/9/20: 37.817 added;; 25/9/20: 38.817 added;; 13/9/21: Compl:0%->60% ; ; 5/4/22: 100%->100
- 1931: 25/9/20: 37.880 added;; 2/7/21: 0%->100
- 1932: TR 38.8xx ; 13/9/21: Compl:0%->100%; 13/9/21: CD:Wed 08/09/21->Tue 21/09/21; 13/9/21: Stat Rep: ->RP- ; 29/9/21: 100%->100; 6/1/22: WID:RP-202870->RP-212892
- 1933: TR 38.8xx ; 29/9/21: 0%->100
- 1934: 5/12/20: 0%->15; 5/12/20: FCD:12/03/2021->09/20; 21/3/21: 15%->30; 13/9/21: 30%->70; 13/9/21: FCD:Wed 08/09/->12/21; 4/6/22: 70%->100
- 1935: 26/6/19: 23.700-094 added;; 8/10/19: 23.700-94 added; 21/1/22: stopped at 0%; 21/1/22: 0%->100
- 1936: 21/1/22: stopped at 0%; 21/1/22: 0%->100
- 1937: 21/1/22: stopped at 0%; 21/1/22: 0%->100
- 1938: 12/9/20: 0%->5; 5/12/20: 5%->15; 5/12/20: FCD:16/12/2020->03/20; 19/3/21: 15%->100. 13/7/22: marked as stopped (was already at 100%!) as per e-mail from Mirko on 02/06/22 14.03
- 1939: -
- 1940: -
- 1941: -
- 1942: 14/3/19: 0%->50
- 1943: 7/6/18: 0%->15¦6/8/18: 23.725 added;¦10/9/18: 15%->60¦7/12/18: 60%->85¦14/3/19: 85%->90; 31/5/19: 90%->95; 13/9/19: 95%->100
- 1944: 7/12/18: 0%->20¦20/3/19: FCD:019->06/19¦20/3/19: 20%->65; 31/5/19: 65%->80; 13/9/19: 80%->100
- 1945: 14/3/19: 0%->50; 31/5/19: 50%->80; 13/9/19: 80%->100
- 1946: 13/9/19: 0%->30; 6/12/19: 30%->80; 6/12/19: FCD:12/12/2019->03/20; 9/4/21: 80%->100

| ID | WBS | Task | Type | Duration | Start | Finish | Complete | Remaining | Total slack | Constraint | Resources | Work | Actual work | Acronym | PCG approved | WI rapporteur name | WI rapporteur e-mail | Release | TSG approved | Impacted TSs and TRs | TSG stopped | Status Report |
| --- | --- | --- | --- | --- | --- | --- | --- | --- | --- | --- | --- | --- | --- | --- | --- | --- | --- | --- | --- | --- | --- | --- |
| 1947 | 872.5 | **CT Aspects of 5G_URLLC** |  | 201d | 2019-06-06 A | 2020-03-12 A | 100% |  |  |  | ct | 6432h | 6432h | 5G_URLLC | 43 | Qi Caixia, Huawei | caixia.qi@huawei.com | Rel-16 | 84 |  |  |  |
| 1948 | 872.5.1 | CT1 Aspects of 5G_URLLC |  | 201d | 2019-06-06 A | 2020-03-12 A | 100% |  |  | finish no earlier than 2020-03-12 | C1 | 1608h | 1608h | 5G_URLLC | 44 | Qi Caixia, Huawei | caixia.qi@huawei.com | Rel-16 | 87 |  |  |  |
| 1949 | 872.5.2 | CT3 Aspects of 5G_URLLC |  | 201d | 2019-06-06 A | 2020-03-12 A | 100% |  |  | finish no earlier than 2020-03-12 | C3 | 1608h | 1608h | 5G_URLLC | 43 | Qi Caixia, Huawei | caixia.qi@huawei.com | Rel-16 | 84 | 29.512; 29.513; 29.514; 29.522; 29.508 |  |  |
| 1950 | 872.5.3 | CT4 Aspects of 5G_URLLC |  | 201d | 2019-06-06 A | 2020-03-12 A | 100% |  |  | finish no earlier than 2020-03-12 | C4 | 1608h | 1608h | 5G_URLLC | 43 | Qi Caixia, Huawei | caixia.qi@huawei.com | Rel-16 | 84 | 29.244; 29.502; 29.503; 29.510; 29.281 |  |  |
| 1951 | 872.6 | Charging enhancement for URLLC |  | 193d | 2020-09-16 A | 2021-06-11 A | 100% |  |  | finish no earlier than 2021-06-12 | S5 | 1544h | 1544h | 5G_URLLC | 45 | Chen, Shan, Huawei | chenshan@huawei.com | Rel-17 | 89 | 32.255; 32.291; 32.298 |  |  |
| 1952 | 872.7 | Management Aspects of URLLC |  | 194d | 2023-06-08 A | 2024-03-03 A | 100% |  |  | finish no earlier than 2024-03-03 | S5 | 1552h | 1552h | URLLC_Mgt |  | Wang Zhaoning, China Unicom, | wangzn18@chinaunicom.cn | Rel-18 | 100 | 28.541; 28.552; 28.554 |  |  |
| 1953 | 872.8 | Stopped - Study on EPC support for Mobility with Low Latency Communication |  | 196d? | 2017-12-15 A | 2018-09-14 A | 100% |  |  | finish no earlier than 2018-09-14 | S2 | 1568h | 1568h | FS_LLC_Mob | 40 | Chris PUDNEY | chris dot pudney at vodafone dot com | Rel-16 | 78 | new 23.739 | 84 |  |
| 1954 | 872.9 | Stopped - Study on enht of systems using EPS for UR and Availability using commodity equipment |  | 197d? | 2018-03-15 A | 2018-12-14 A | 100% |  |  | start no earlier than 2018-03-15 | S2 | 1576h | 1576h | FS_EPS_URACE | 40 | Chris Pudney | chris.pudney@vodafone.com | Rel-16 | 79 | new; 23.736 | 84 |  |
| 1955 | 873 | **Physical Layer Enhancements for NR Ultra-Reliable and Low Latency Communication (URLLC)** |  | 1435d? | 2018-06-15 A | 2023-12-12 | 99% | 0d? | 0d |  | R1 | 24632h | 15651.7h | NR_L1enh_URLLC | 42 | Huawei |  | Rel-16 | 83 |  |  |  |
| 1956 | 873.1 | Study on physical layer enhancements for NR UR Low Latency Cases |  | 196d? | 2018-06-15 A | 2019-03-15 A | 100% |  |  | finish no earlier than 2019-03-15 | R1 | 1568h | 1568h | FS_NR_L1enh_URLLC | 41 | Huawei |  | Rel-16 | 80 |  |  |  |
| 1957 | 873.2 | Core part: Physical Layer Enhancements for NR URLLC |  | 261d | 2019-03-01 A | 2020-02-28 A | 100% |  |  | finish no earlier than 2020-03-01 | R1 | 2088h | 2088h | NR_L1enh_URLLC-Core | 42 | Huawei |  | Rel-16 | 83 |  |  |  |
| 1958 | 873.3 | Perf. part: Physical Layer Enhancements for NR URLLC |  | 403d | 2019-03-01 A | 2020-09-15 A | 100% |  |  | finish no earlier than 2020-09-15 | R4 | 3224h | 3224h | NR_L1enh_URLLC-Perf | 42 | Huawei |  | Rel-16 | 83 |  |  |  |
| 1959 | 873.4 | UE Conformance Test Aspects - Physical Layer Enhancements for NR URLLC |  | 784d | 2020-12-14 A | 2023-12-12 A | 100% |  |  | finish no earlier than 2023-12-12 | R5 | 6272h | 6272h | NR_L1enh_URLLC-UEConTest | 46 | Chunying GU, Huawei | guchunying@huawei.com | Rel-16 | 90 |  |  | RP-233758 |
| 1960 | 874 | **Support of NR Industrial Internet of Things (IoT)** |  | 977d? | 2018-06-15 A | 2022-03-11 A | 100% |  |  |  | R2 | 17152h | 17152h | NR_IIOT | 42 | Nokia |  | Rel-16 | 83 |  |  |  |
| 1961 | 874.1 | Study on channel modeling for indoor industrial scenarios |  | 261d? | 2018-09-14 A | 2019-09-13 A | 100% |  |  | finish no earlier than 2019-09-13 | R1 | 2088h | 2088h | FS_IIIOT_CM | 41 | Ericsson |  | Rel-16 | 81 |  |  |  |
| 1962 | 874.2 | Study on NR Industrial Internet of Things (IoT) |  | 196d? | 2018-06-15 A | 2019-03-15 A | 100% |  |  | finish no earlier than 2019-03-15 | R2 | 1568h | 1568h | FS_NR_IIOT | 41 | Nokia |  | Rel-16 | 80 | 38.825 |  |  |
| 1963 | 874.3 | Core part: Support of NR Industrial Internet of Things (IoT) |  | 261d | 2019-03-01 A | 2020-02-28 A | 100% |  |  | finish no earlier than 2020-03-01 | R2 | 2088h | 2088h | NR_IIOT-Core | 42 | Nokia |  | Rel-16 | 83 |  |  |  |
| 1964 | 874.4 | UE Conformance Test Aspects – Support of NR Industrial Internet of Things (IoT) |  | 450d | 2020-06-22 A | 2022-03-11 A | 100% |  |  | finish no earlier than 2022-03-12 | R5 | 3600h | 3600h | NR_IioT-UEConTest | 45 | CMCC |  | Rel-16 | 88 |  |  | RP-220623 |
| 1965 | 875 | 5GS Enhanced support of Vertical and LAN Services | milestone | 0d? | 2017-12-15 A | 2017-12-15 A | 100% |  |  |  |  |  |  |  | 42 |  |  | Rel-16 | 82 |  |  |  |
| 1966 | 876 | Study on Communication for Automation in Vertical Domains |  | 271d? | 2017-03-02 A | 2018-03-15 A | 100% |  |  | finish no earlier than 2018-03-15 | S1 | 2168h | 2168h | FS_CAV | 38 | Walewski, Joachim, Siemens AG | joachim.walewski@siemens.com | Rel-16 | 75 | 22.804 |  |  |
| 1967 | 877 | Service requirements for cyber-physical control applications in vertical domains |  | 73d? | 2018-06-06 A | 2018-09-14 A | 100% |  |  | finish no earlier than 2018-09-14 | S1 | 584h | 584h | cyberCAV | 41 | Joachim W. Walewski (Siemens) |  | Rel-16 | 80 | 22.261; 22.104 |  |  |
| 1968 | 878 | **5GS Enhanced support of Vertical and LAN Services** |  | 462d? | 2018-06-06 A | 2020-03-12 A | 100% |  |  |  |  | 14816h | 14816h | Vertical_LAN | 42 | Devaki Chandramouli, Nokia | Devaki.chandramouli@nokia.com | Rel-16 | 82 |  |  |  |
| 1969 | 878.1 | Study on 5GS Enhanced support of Vertical and LAN Services |  | 138d? | 2018-06-06 A | 2018-12-14 A | 100% |  |  | finish no earlier than 2018-12-14 | S2 | 1104h | 1104h | FS_Vertical_LAN | 41 | Devaki Chandramouli, Nokia | Devaki.chandramouli@nokia.com | Rel-16 | 80 | 23.734 |  |  |
| 1970 | 878.2 | Stage 2 of Vertical_LAN |  | 138d | 2018-12-13 A | 2019-06-24 A | 100% |  |  | start no earlier than 2018-12-13 | S2 | 1104h | 1104h | Vertical_LAN | 42 | Devaki Chandramouli, Nokia | Devaki.chandramouli@nokia.com | Rel-16 | 82 | 23.501; 23.502; 23.503 |  |  |
| 1971 | 878.3 | Study on Security for 5GS Enhanced support of Vertical and LAN Services |  | 331d? | 2018-09-06 A | 2019-12-12 A | 100% |  |  | finish no earlier than 2019-12-12 | S3 | 2648h | 2648h | FS_Vertical_LAN_SEC | 41 | Jerichow, Anja (Nokia) | anja.jerichow@nokia.com | Rel-16 | 81 | New |  |  |
| 1972 | 878.4 | Security for Vertical_LAN |  | 201d | 2019-06-06 A | 2020-03-12 A | 100% |  |  | finish no earlier than 2020-03-12 | S3 | 1608h | 1608h | Vertical_LAN_SEC | 43 | Jerichow, Anja, Nokia | anja.jerichow@nokia.com | Rel-16 | 84 | 33.501 |  |  |

Notes:
- 1947: 16/9/19: WID:CP-191063->CP-192022
- 1948: 26/3/20: CT1 aspects added as per Peter's e-mail; 26/3/20: 0%->100
- 1949: 13/9/19: 0%->50; 6/12/19: 50%->80; 26/3/20: 80%->100
- 1950: 31/5/19: 0%->5; 13/9/19: 5%->20; 6/12/19: 20%->60; 26/3/20: 60%->98; 26/6/20: 98%->100
- 1951: ; 5/12/20: 0%->20; 5/12/20: FCD:12/03/2021->06/20; 21/3/21: 20%->30; 13/9/21: 30%->100
- 1952: ; 7/9/23: 0%->10; 8/12/23: 10%->20; 14/3/24: 20%->100
- 1953: 16/3/18: 0%->35¦7/6/18: 35%->75¦6/6/19: stopped at 75% as per SP-190395
- 1954: 7/6/18: 0%->10¦6/8/18: 23.736 added¦6/6/19: stopped at 10% as per SP-190395; 6/6/19: 10%->100
- 1955: 26/6/19: WID:RP-190726->RP-191584
- 1956: TR 38.8xx¦26/3/19: 0%->100
- 1957: 26/3/20: 0%->100
- 1958: 7/4/21: 0%->100
- 1959: tested: REL-16 WI NR_L1enh_URLLC-Core ; 8/4/21: 0%->5; 2/7/21: 5%->16; 22/3/22: Compl:16 ; 20/6/22: Rapporteur: Huawei->Chunying GU, Huawei; Rap eMail: ->guchunying@huawei.com; 9/12/22: FCD:22/12/2022->01/12/2023; Compl:90%->91%; Stat Rep: RP-2214.....; 8/12/23: Compl:99%->100%; Stat Rep: RP-232349->RP-233758;
- 1960: 26/6/19: WID:RP-190728->RP-191561; 8/10/19: WID:RP-191561->RP-192324; 14/1/20: WID:RP-192324->RP-192590
- 1961: 8/10/19: 0%->100
- 1962: TR 38.8XX?¦6/8/18: 38.825 added;¦26/3/19: 0%->100
- 1963: 28/7/20: WID:RP-192590->RP-200797; 28/7/20: 0%->100
- 1964: 8/10/20: 0%->5; 8/4/21: 5%->68; 2/7/21: 68%->77; 13/9/21: Compl:77%->95%; 13/9/21: C ; 29/9/21: WID:RP-200757->RP-211786; 6/1/22: WID:RP-211786->RP-212943;
- 1965: -
- 1966: 7/6/17: 0%->30¦25/8/17: FCD:12/17->03/18¦11/9/17: 30%->65¦15/12/17: 65%->85¦16/3/18: 85%->95¦7/6/18: 95%->100
- 1967: 10/9/18: 5%->40¦4/12/18: 40%->100
- 1969: 10/9/18: 0%->25¦7/12/18: 25%->88¦14/3/19: 88%->92; 31/5/19: 92%->100
- 1970: 14/3/19: 0%->43; 31/5/19: 43%->90; 13/9/19: 90%->97; 6/12/19: 97%->100
- 1971: 7/12/18: 0%->10¦20/3/19: FCD:019->06/19¦20/3/19: 10%->65; 31/5/19: 65%->75; 13/9/19: FCD:12/06/2019->12/20; 13/9/19: 75%->78; 6/12/19: 78%->92; 25/3/20: 92%->100
- 1972: 13/9/19: 0%->30; 6/12/19: 30%->95; 6/12/19: FCD:12/12/2019->03/20; 26/6/20: 95%->100

| ID | WBS | Task | Type | Duration | Start | Finish | Complete | Remaining | Total slack | Constraint | Resources | Work | Actual work | Acronym | PCG approved | WI rapporteur name | WI rapporteur e-mail | Release | TSG approved | Status Report |
| --- | --- | --- | --- | --- | --- | --- | --- | --- | --- | --- | --- | --- | --- | --- | --- | --- | --- | --- | --- | --- |
| 1973 | 878.5 | **CT aspects of Vertical_LAN** |  | 261d | 2019-03-14 A | 2020-03-12 A | 100% |  |  |  | ct | 8352h | 8352h | Vertical_LAN | 42 | WON, Sung Hwan, Nokia | sung.won@nokia.com | Rel-16 | 83 |  |
| 1974 | 878.5.1 | CT1 aspects of Vertical_LAN |  | 261d | 2019-03-14 A | 2020-03-12 A | 100% |  |  | finish no earlier than 2020-03-12 | C1 | 2088h | 2088h | Vertical_LAN | 42 | WON, Sung Hwan, Nokia | sung.won@nokia.com | Rel-16 | 83 |  |
| 1975 | 878.5.2 | CT3 aspects of Vertical_LAN |  | 261d | 2019-03-14 A | 2020-03-12 A | 100% |  |  | finish no earlier than 2020-03-12 | C3 | 2088h | 2088h | Vertical_LAN | 42 | WON, Sung Hwan, Nokia | sung.won@nokia.com | Rel-16 | 83 |  |
| 1976 | 878.5.3 | CT4 aspects of Vertical_LAN |  | 261d | 2019-03-14 A | 2020-03-12 A | 100% |  |  | finish no earlier than 2020-03-12 | C4 | 2088h | 2088h | Vertical_LAN | 42 | WON, Sung Hwan, Nokia | sung.won@nokia.com | Rel-16 | 83 |  |
| 1977 | 879 | **Service Enabler Architecture Layer for Verticals** |  | 332d | 2019-03-07 A | 2020-06-12 A | 100% |  |  |  |  | 5568h | 5568h | SEAL | 42 | Basavaraj (Basu) Pattan, Samsung | basavarajjp@samsung.com | Rel-16 | 85 |  |
| 1978 | 879.1 | Stage 2 of SEAL |  | 126d | 2019-03-07 A | 2019-08-29 A | 100% |  |  |  | S6 | 1008h | 1008h | SEAL | 42 | Basavaraj (Basu) Pattan, Samsung | basavarajjp@samsung.com | Rel-16 | 82 |  |
| 1979 | 879.2 | Security aspects of SEAL |  | 192d | 2019-09-19 A | 2020-06-12 A | 100% |  |  | finish no earlier than 2020-06-12 | S3 | 1536h | 1536h | SEAL | 43 | Rajavelsamy Rajadurai (Samsung) | rajvel@samsung.com | Rel-16 | 85 |  |
| 1980 | 879.3 | **CT aspects of SEAL** |  | 126d | 2019-09-19 A | 2020-03-12 A | 100% |  |  |  | ct | 3024h | 3024h | SEAL | 43 | Sapan Shah (Samsung Electronics) | sapan.shah@samsung.com | Rel-16 | 85 |  |
| 1981 | 879.3.1 | CT1 aspects of SEAL |  | 126d | 2019-09-19 A | 2020-03-12 A | 100% |  |  | finish no earlier than 2020-03-12 | C1 | 1008h | 1008h | SEAL | 43 | Sapan Shah (Samsung Electronics) | sapan.shah@samsung.com | Rel-16 | 85 |  |
| 1982 | 879.3.2 | CT3 aspects of SEAL |  | 126d | 2019-09-19 A | 2020-03-12 A | 100% |  |  | finish no earlier than 2020-03-12 | C3 | 1008h | 1008h | SEAL | 43 | Sapan Shah (Samsung Electronics) | sapan.shah@samsung.com | Rel-16 | 85 |  |
| 1983 | 880 | **NR-based access to unlicensed spectrum** |  | 719d? | 2017-03-15 A | 2019-12-15 | 86% | 100.01d? |  |  | R1 | 20400h | 7856h | NR_unlic | 42 | Qualcomm |  | Rel-16 | 82 |  |
| 1984 | 880.1 | Study on NR-based access to unlicensed spectrum |  | 458d? | 2017-03-15 A | 2018-12-14 A | 100% |  |  | finish no earlier than 2018-12-15 | R1 | 3664h | 3664h | FS_NR_unlic | 38 | Qualcomm |  | Rel-16 | 75 |  |
| 1985 | 880.2 | Core part: NR-based access to unlicensed spectrum | manual | 262d | 2018-12-15 A | 2019-12-15 A | 100% |  |  |  | R1 | 2096h | 2096h | NR_unlic-Core | 42 | Qualcomm |  | Rel-16 | 82 |  |
| 1986 | 880.3 | Perf. part: NR-based access to unlicensed spectrum | manual | 262d | 2018-12-15 A | 2019-12-15 A | 100% |  |  |  | R4 | 2096h | 2096h | NR_unlic-Perf | 42 | Qualcomm |  | Rel-16 | 82 |  |
| 1987 | 880.4 | UE Conformance Test Aspects - NR-based access to unlicensed spectrum |  | 849d | 2021-03-12 A | 2024-06-06 | 70% | 254.7d | 453d | finish no earlier than 2024-06-06 | R5 | 6792h |  | NR_unlic-UEConTest | 46 | Vijay Balasubramanian, Qualcomm | vijayb[at]qti.qualcomm.com | Rel-16 | 91 | RP-240338 |
| 1988 | 881 | **LAN support in 5G** |  | 400d? | 2017-06-05 A | 2018-12-14 A | 100% |  |  |  | S1 | 4304h | 4304h | 5GLAN | 41 | Almodovar Chico, Jose Luis, KPN | jose.almodovarchico@tno.nl | Rel-16 | 80 |  |
| 1989 | 881.1 | Study on LAN Support in 5G |  | 204d? | 2017-06-05 A | 2018-03-15 A | 100% |  |  | finish no earlier than 2018-03-15 | S1 | 1632h | 1632h | FS_5GLAN | 39 | Nasielski, Jack, Qualcomm Incorporated | jackn@qti.qualcomm.com | Rel-16 | 76 |  |
| 1990 | 881.2 | Stage 1 of 5GLAN |  | 138d? | 2018-06-06 A | 2018-12-14 A | 100% |  |  | finish no earlier than 2018-12-14 | S1 | 1104h | 1104h | 5GLAN | 41 | Almodovar Chico, Jose Luis, KPN | jose.almodovarchico@tno.nl | Rel-16 | 80 |  |
| 1991 | 882 | Study on non-public networks management |  | 331.88d | 2019-03-07 A | 2020-06-12 A | 100% |  |  | finish no earlier than 2020-06-12 | S5 | 2655h | 2655h | FS_OAM_NPN | 42 | ZHANG, Kai, Huawei | kai.zhangkai@huawei.com | Rel-16 | 83 |  |
| 1992 | 883 | Cellular IoT support and evolution | milestone | 0d? | 2016-06-18 A | 2016-06-18 A | 100% |  |  |  |  |  |  |  |  |  |  | Rel-16 |  |  |
| 1993 | 884 | **Cellular IoT support and evolution for the 5G System** |  | 721d? | 2017-09-08 A | 2020-06-12 A | 100% |  |  |  |  | 15712h | 15712h | 5G_CIoT | 42 |  |  | Rel-16 | 83 |  |
| 1994 | 884.1 | Study on 5G_CIoT |  | 331d? | 2017-09-08 A | 2018-12-14 A | 100% |  |  | finish no earlier than 2018-12-14 | S2 | 2648h | 2648h | FS_CIoT_5G | 39 | Sebastian Speicher | sspeiche@qti.qualcomm.com | Rel-16 | 77 |  |
| 1995 | 884.2 | Stage 2 of 5G_CIoT |  | 136d | 2018-12-13 A | 2019-06-20 A | 100% |  |  | start no earlier than 2018-12-13 | S2 | 1088h | 1088h | 5G_CIoT | 42 | Sebastian Speicher | sspeiche@qti.qualcomm.com | Rel-16 | 82 |  |
| 1996 | 884.3 | **CT aspects of 5G_CIoT** |  | 261d | 2019-03-14 A | 2020-03-12 A | 100% |  |  |  | ct | 10440h | 10440h | 5G_CIoT | 42 | Waqar Zia; Qualcomm Incorporated | wzia@qti.qualcomm.com | Rel-16 | 83 |  |
| 1997 | 884.3.1 | CT1 aspects of 5G_CIoT |  | 261d | 2019-03-14 A | 2020-03-12 A | 100% |  |  | finish no earlier than 2020-03-12 | C1 | 2088h | 2088h | 5G_CIoT | 42 | Waqar Zia; Qualcomm Incorporated | wzia@qti.qualcomm.com | Rel-16 | 83 |  |
| 1998 | 884.3.2 | CT3 aspects of 5G_CIoT |  | 261d | 2019-03-14 A | 2020-03-12 A | 100% |  |  | finish no earlier than 2020-03-12 | C3 | 2088h | 2088h | 5G_CIoT | 42 | Waqar Zia; Qualcomm Incorporated | wzia@qti.qualcomm.com | Rel-16 | 83 |  |
| 1999 | 884.3.3 | CT4 aspects of 5G_CIoT |  | 261d | 2019-03-14 A | 2020-03-12 A | 100% |  |  | finish no earlier than 2020-03-12 | C4 | 2088h | 2088h | 5G_CIoT | 42 | Waqar Zia; Qualcomm Incorporated | wzia@qti.qualcomm.com | Rel-16 | 83 |  |
| 2000 | 884.3.4 | CT6 aspects of 5G_CIoT |  | 261d | 2019-03-14 A | 2020-03-12 A | 100% |  |  | finish no earlier than 2020-03-12 | C6 | 2088h | 2088h | 5G_CIoT | 42 | Waqar Zia; Qualcomm Incorporated | wzia@qti.qualcomm.com | Rel-16 | 83 |  |
| 2001 | 884.4 | Security of 5G_CIoT |  | 192d | 2019-09-19 A | 2020-06-12 A | 100% |  |  | finish no earlier than 2020-06-12 | S3 | 1536h | 1536h | 5G_CIoT | 43 | Henrik Normann, Ericsson | henrik.normann@ericsson.com | Rel-16 | 85 |  |
| 2002 | 885 | Study on evolution of Cellular IoT security for the 5G System |  | 397d? | 2018-06-06 A | 2019-12-12 A | 100% |  |  | finish no earlier than 2019-12-12 | S3 | 3176h | 3176h | FS_CIoT_sec_5G | 41 | Noamen Ben Henda | noamen.ben.henda@ericsson.com | Rel-16 | 80 |  |
| 2003 | 886 | Study on MBMS User Services for IoT |  | 335d? | 2017-06-05 A | 2018-09-14 A | 100% |  |  | finish no earlier than 2018-09-14 | S4 | 2680h | 2680h | FS_MBMS_IoT | 39 | Cedric thienot, Expway | cedric (dot) thienot (at) expway (dot) com | Rel-16 | 76 |  |

Notes:
- 1973: 3/6/19: WID:CP-190195->CP-191157; 16/9/19: WID:CP-191157->CP-192258; 9/12/19: WID:CP-192258->CP-193142; 9/12/19: WID:CP-193142->CP-193272
- 1974: 31/5/19: 0%->20; 3/6/19: WID:CP-190195->CP-191157; 3/6/19: FCD:12/12/2019->03/20; 13/9/19: 20%->75; 6/12/19: 75%->90; 26/3/20: 90%->95; 26/6/20: 95%->99; 13/9/20: 99%->100 / Impacted TSs and TRs: 23.122; 24.368; 24.501; 24.526
- 1975: 31/5/19: FCD:12/12/2019->03/20; 3/6/19: WID:CP-190195->CP-191157; 13/9/19: 0%->30; 6/12/19: 30%->60; 6/12/19: WID:CP-192258->CP-193142; 26/3/20: 60%->100; 26/6/20: WID:CP-193272->CP-201174 / Impacted TSs and TRs: 29.122; 29.507; 29.508; 29.512; 29.513; 29.514; 29.519; 29.520; 29.521; 29.522; 29.523; 29.525; 29.554; 29.561; 29.594; 29.061
- 1976: 31/5/19: 0%->5; 3/6/19: WID:CP-190195->CP-191157; 3/6/19: FCD:12/12/2019->03/20; 13/9/19: 5%->50; 6/12/19: 50%->85; 26/3/20: 85%->95; 26/6/20: 95%->100 / Impacted TSs and TRs: 23.003; 23.008; 29.502; 29.503; 29.505; 29.509; 29.510; 29.518; 29.571; 29.244; 29.281
- 1977: 14/3/19: 0%->60; 31/5/19: 60%->95; 8/10/19: 33.434 added;; 8/10/19: 24.548 added; / Impacted TSs and TRs: new 23.434; 33.434; 24.548; 24.547
- 1978: 14/3/19: 0%->60; 31/5/19: 60%->95; 13/9/19: 0%->100 / Impacted TSs and TRs: new 23.434
- 1979: ; 6/12/19: 0%->40; 25/3/20: 40%->65; 25/3/20: FCD:12/03/2020->06/20; 26/6/20: 65%->100 / Impacted TSs and TRs: New
- 1980: Impacted TSs and TRs: New
- 1981: ; 6/12/19: 0%->60; 6/12/19: 60%->60; 26/3/20: 60%->80; 26/6/20: 80%->100 / Impacted TSs and TRs: New
- 1982: ; 26/3/20: 0%->75; 26/6/20: 75%->100 / Impacted TSs and TRs: New
- 1983: 26/3/19: WID:RP-182878->RP-190706; 26/6/19: WID:RP-190706->RP-191575; 14/1/20: WID:RP-191575->RP-192926; 25/9/20: WID:RP-192926->RP-201834
- 1984: TR 38.8XX19/6/17: WID: RP-170828->RP-171416¦30/6/17: 32.889 added;¦19/9/17: WID: RP-171416->RP-17202127/3/18: Compl:0%->10%¦27/6/18: Compl:10%->40%¦27/6/18: CD:Fri 15/06/18->Sat 15/12/18¦16/1/19: 40%->100 / Impacted TSs and TRs: 32.889
- 1985: 26/3/19: WID:RP-182878->RP-190706; 6/1/21: 0%->100
- 1986: 26/3/19: WID:RP-182878->RP-190706; 2/7/21: 0%->100
- 1987: tested: REL-16 WI NR_unlic-Core ; 2/7/21: 0%->5 ; ; 6/6/22: Compl:18%->20% 20/6/22: Rapporteur: Qualcomm->Vijay Balasubramanian, Qualcomm; Rap eMail: ->vijayb[at]qti.qualcomm.com ; 9/...; 9/12/22: FCD:22/12/2022->01/06/2023; Compl:25%->28%; Stat Re...; 14/3/24: FCD:05/06/2024->06/06/2024; Compl:65%->70%; Stat Rep: RP-233872->RP-240338;
- 1988: 11/3/22: 99%->100 / Impacted TSs and TRs: 22.261; 22.278
- 1989: 11/9/17: 0%->35¦15/12/17: 35%->65¦16/3/18: 65%->100 / Impacted TSs and TRs: 22.821;
- 1990: 10/9/18: 40%->75¦10/9/18: FCD:09/18->12/18¦4/12/18: 75%->100 / Impacted TSs and TRs: 22.261; 22.278
- 1991: 31/5/19: 0%->2; 13/9/19: 2%->10; 26/3/20: 10%->70; 26/3/20: FCD:05/12/2019->06/20; 28/6/20: 70%->100 / Impacted TSs and TRs: New
- 1992: -
- 1994: 11/09/17: rapporteur change¦15/12/17: 23.724 added;¦16/3/18: 0%->20¦7/6/18: 20%->50¦15/6/18: WID:SP-170801->SP-180614¦15/6/18: FCD:09/18->12/18¦10/9/18: 50%->70¦7/12/18: 70%->95; 31/5/19: 95%->100 / Impacted TSs and TRs: New; 23.724
- 1995: 14/3/19: 0%->50; 31/5/19: 50%->95; 13/9/19: 95%->98; 22/3/22: 98%->100 / Impacted TSs and TRs: 23.501; 23.502
- 1996: 3/6/19: WID:CP-190198->CP-111158; 9/12/19: WID:CP-111237->CP-193274; 25/3/20: WID:CP-193274->CP-200147
- 1997: 31/5/19: 0%->40; 3/6/19: WID:CP-190198->CP-111158; 3/6/19: FCD:12/12/2019->03/20; 13/9/19: 40%->60; 6/12/19: 60%->85; 26/3/20: 85%->92; 26/6/20: 92%->99; 13/9/20: 99%->100 / Impacted TSs and TRs: 23.122; 24.250; 24.301; 24.368; 24.501; 27.007
- 1998: 31/5/19: 0%->15; 3/6/19: WID:CP-190198->CP-111158; 3/6/19: FCD:12/12/2019->03/20; 13/9/19: 15%->40; 6/12/19: 40%->65; 6/12/19: WID:CP-111237->CP-193147; 26/3/20: 65%->90; 26/6/20: 90%->100 / Impacted TSs and TRs: 29.122; 29.522; 29.525; 29.222; 29.512; 29.513; 29.514
- 1999: 31/5/19: 0%->10; 3/6/19: WID:CP-190198->CP-111158; 3/6/19: FCD:12/12/2019->03/20; 13/9/19: 10%->25; 6/12/19: 25%->60; 26/3/20: 60%->90; 26/6/20: 90%->100 / Impacted TSs and TRs: 23.008; 29.274; 29.502; 29.503; 29.505; 29.518
- 2000: 3/6/19: WID:CP-190198->CP-111158; 3/6/19: FCD:12/12/2019->03/20; 26/3/20: 0%->100 / Impacted TSs and TRs: TBD
- 2001: 6/12/19: 0%->50; 6/12/19: FCD:12/12/2019->03/20; 25/3/20: 50%->90; 25/3/20: FCD:12/03/2020->06/20; 26/6/20: 90%->100 / Impacted TSs and TRs: 33.501
- 2002: 6/8/18: 33.861 added;¦7/12/18: 5%->30¦20/3/19: 30%->75¦20/3/19: FCD:019->09/19; 31/5/19: 75%->80; 13/9/19: FCD:12/09/2019->12/20; 13/9/19: 80%->90; 6/12/19: 90%->95; 26/6/20: 95%->100 / Impacted TSs and TRs: New; 33.861
- 2003: 11/9/17: 0%->10¦15/12/17: 10%->30¦16/3/18: 30%->80¦16/3/18: FCD:03/18->06/18¦7/6/18: 80%->90¦7/6/18: FCD:06/18->09/18. 14/06/18: Moved from Rel-15¦10/9/18: 90%->100 / Impacted TSs and TRs: 26.8xx

| ID | WBS | Task | Type | Duration | Start | Finish | Complete | Constraint | Resources | Work | Actual work | Acronym | PCG approved | WI rapporteur name | Release | TSG approved | WI rapporteur e-mail | Status Report |
| --- | --- | --- | --- | --- | --- | --- | --- | --- | --- | --- | --- | --- | --- | --- | --- | --- | --- | --- |
| 2004 | 887 | **Additional MTC enhancements for LTE** |  | 522d? | 2018-06-15 A | 2020-06-15 A | 100% |  | R1 | 11480h | 11480h | LTE_eMTC5 | 41 | Ericsson | Rel-16 | 80 |  |  |
| 2005 | 887.1 | Core part: Additional MTC enhancements for LTE |  | 391d? | 2018-06-15 A | 2019-12-13 A | 100% | finish no earlier than 2019-12-15 | R1 | 3128h | 3128h | LTE_eMTC5-Core | 41 | Ericsson | Rel-16 | 80 |  |  |
| 2006 | 887.2 | Perf. part: Additional MTC enhancements for LTE |  | 522d? | 2018-06-15 A | 2020-06-15 A | 100% | finish no earlier than 2020-06-15 | R4 | 4176h | 4176h | LTE_eMTC5-Perf | 41 | Ericsson | Rel-16 | 80 |  |  |
| 2007 | 888 | **Additional enhancements for NB-IoT** |  | 522d? | 2018-06-15 A | 2020-06-15 A | 100% |  | R1 | 11480h | 11480h | NB_IOTenh3 | 41 | Huawei | Rel-16 | 80 |  |  |
| 2008 | 888.1 | Core part: Additional enhancements for NB-IoT |  | 391d? | 2018-06-15 A | 2019-12-13 A | 100% | finish no earlier than 2019-12-15 | R1 | 3128h | 3128h | NB_IOTenh3-Core | 41 | Huawei | Rel-16 | 80 |  |  |
| 2009 | 888.2 | Perf. part: Additional enhancements for NB-IoT |  | 522d? | 2018-06-15 A | 2020-06-15 A | 100% | finish no earlier than 2020-06-15 | R4 | 4176h | 4176h | NB_IOTenh3-Perf | 41 | Huawei | Rel-16 | 80 |  |  |
| 2010 | 889 | **5G message service** |  | 650.2d? | 2016-06-18 A | 2018-12-14 A | 100% |  | S1 | 7905.6h | 7905.6h | 5GMSG | 41 |  | Rel-16 | 81 |  |  |
| 2011 | 889.1 | Study on 5G message service for MIoT |  | 266d? | 2016-06-18 A | 2018-09-14 A | 100% | finish no earlier than 2018-09-14 | S1 | 2128h | 2128h | FS_5GMSG | 39 | Zheng, Jianping, China Mobile | Rel-16 | 77 | zhengjianping@chinamobile.com |  |
| 2012 | 889.2 | Message Service Within the 5G System requirements |  | 72d? | 2018-09-06 A | 2018-12-14 A | 100% | finish no earlier than 2018-12-14 | S1 | 576h | 576h | MSGin5G | 41 | Zheng, Jianping, China Mobile | Rel-16 | 81 | zhengjianping@chinamobile.com |  |
| 2013 | 890 | Advanced V2X support | milestone | 0d? | 2017-06-05 A | 2017-06-05 A | 100% |  |  |  |  |  |  |  | Rel-16 |  |  |  |
| 2014 | 891 | Study on Improvement of V2X Service Handling |  | 66d? | 2018-03-15 A | 2018-06-14 A | 100% | finish no earlier than 2018-06-14 | S1 | 528h | 528h | FS_V2XIMP | 40 | SungDuck Chun; LG Electronics | Rel-16 | 79 | sungduck.chun@lge.com |  |
| 2015 | 892 | Improvement of V2X service Handling |  | 29d | 2018-10-25 A | 2018-12-04 A | 100% | finish no earlier than 2018-12-04 | S1 | 232h | 232h | V2XIMP | 42 | SungDuck Chun; LG Electronics | Rel-16 | 82 | sungduck.chun@lge.com |  |
| 2016 | 893 | **Application layer support for V2X services** |  | 585d? | 2017-12-15 A | 2020-03-12 A | 100% |  |  | 9616h | 9616h | V2XAPP | 41 | Niranth Amogh, Huawei Telecommunications India | Rel-16 | 84 | namogh@huawei.com |  |
| 2017 | 893.1 | Study on V2XAPP |  | 196d? | 2017-12-15 A | 2018-09-14 A | 100% | finish no earlier than 2018-09-14 | S6 | 1568h | 1568h | FS_V2XAPP | 40 | Niranth Amogh, Huawei Telecommunications India | Rel-16 | 78 | namogh@huawei.com |  |
| 2018 | 893.2 | Stage 2 of V2XAPP |  | 202d? | 2018-09-06 A | 2019-06-14 A | 100% | finish no earlier than 2019-06-14 | S6 | 1616h | 1616h | V2XAPP | 41 | Niranth Amogh, Huawei Telecommunications India | Rel-16 | 81 | namogh@huawei.com |  |
| 2019 | 893.3 | **CT aspects of V2XAPP** |  | 201d | 2019-06-06 A | 2020-03-12 A | 100% |  | ct | 6432h | 6432h | V2XAPP | 43 | Herrero Veron, Christian (Huawei) | Rel-16 | 84 | Christian.Herrero at huawei.com |  |
| 2020 | 893.3.1 | CT1 aspects of V2XAPP |  | 201d | 2019-06-06 A | 2020-03-12 A | 100% | finish no earlier than 2020-03-12 | C1 | 1608h | 1608h | V2XAPP | 43 | Herrero Veron, Christian (Huawei) | Rel-16 | 84 | Christian.Herrero at huawei.com |  |
| 2021 | 893.3.2 | CT3 aspects of V2XAPP |  | 201d | 2019-06-06 A | 2020-03-12 A | 100% | finish no earlier than 2020-03-12 | C3 | 1608h | 1608h | V2XAPP | 43 | Herrero Veron, Christian (Huawei) | Rel-16 | 84 | Christian.Herrero at huawei.com |  |
| 2022 | 893.3.3 | CT4 aspects of V2XAPP |  | 201d | 2019-06-06 A | 2020-03-12 A | 100% | finish no earlier than 2020-03-12 | C4 | 1608h | 1608h | V2XAPP | 43 | Herrero Veron, Christian (Huawei) | Rel-16 | 84 | Christian.Herrero at huawei.com |  |
| 2023 | 894 | **Architecture enhancements for 3GPP support of advanced V2X services** |  | 724d? | 2017-06-05 A | 2020-03-12 A | 100% |  |  | 12856h | 12856h | eV2XARC | 43 | LaeYoung Kim, LG Electronics | Rel-16 | 84 | laeyoung.kim@lge.com |  |
| 2024 | 894.1 | Study on eV2XARC |  | 400d? | 2017-06-05 A | 2018-12-14 A | 100% | finish no earlier than 2018-12-14 | S2 | 3200h | 3200h | FS_eV2XARC | 39 | LaeYoung Kim, LG Electronics | Rel-16 | 76 | laeyoung.kim@lge.com | SP-170412 |
| 2025 | 894.2 | Stage 2 of eV2XARC |  | 132d | 2018-12-13 A | 2019-06-14 A | 100% | finish no earlier than 2019-06-14 | S2 | 1056h | 1056h | eV2XARC | 42 | LaeYoung Kim, LG Electronics | Rel-16 | 82 | laeyoung.kim@lge.com |  |
| 2026 | 894.3 | **CT aspects of eV2XARC** |  | 201d | 2019-06-06 A | 2020-03-12 A | 100% |  | ct | 8040h | 8040h | eV2XARC | 43 | Herrero Veron, Christian (Huawei) | Rel-16 | 84 | Christian.Herrero at huawei.com |  |
| 2027 | 894.3.1 | CT1 aspects of eV2XARC |  | 201d | 2019-06-06 A | 2020-03-12 A | 100% | finish no earlier than 2020-03-12 | C1 | 1608h | 1608h | eV2XARC | 43 | Herrero Veron, Christian (Huawei) | Rel-16 | 84 | Christian.Herrero at huawei.com |  |
| 2028 | 894.3.2 | CT3 aspects of eV2XARC |  | 201d | 2019-06-06 A | 2020-03-12 A | 100% | finish no earlier than 2020-03-12 | C3 | 1608h | 1608h | eV2XARC | 43 | Herrero Veron, Christian (Huawei) | Rel-16 | 84 | Christian.Herrero at huawei.com |  |
| 2029 | 894.3.3 | CT4 aspects of eV2XARC |  | 201d | 2019-06-06 A | 2020-03-12 A | 100% | finish no earlier than 2020-03-12 | C4 | 1608h | 1608h | eV2XARC | 43 | Herrero Veron, Christian (Huawei) | Rel-16 | 84 | Christian.Herrero at huawei.com |  |
| 2030 | 894.3.4 | CT6 aspects of eV2XARC |  | 201d | 2019-06-06 A | 2020-03-12 A | 100% | finish no earlier than 2020-03-12 | C6 | 1608h | 1608h | eV2XARC | 43 | Herrero Veron, Christian (Huawei) | Rel-16 | 84 | Christian.Herrero at huawei.com |  |
| 2031 | 894.4 | Security Aspects of eV2XARC |  | 70d | 2019-12-06 A | 2020-03-12 A | 100% | finish no earlier than 2020-03-12 | S3 | 560h | 560h | eV2XARC | 44 | Dongjoo Kim, LG Electronics Inc. | Rel-16 | 86 | dongjoo7.kim@lge.com |  |
| 2032 | 895 | Study on NR Vehicle-to-Everything (V2X) |  | 196d? | 2018-06-15 A | 2019-03-15 A | 100% | finish no earlier than 2019-03-15 | R1 | 1568h | 1568h | FS_NR_V2X | 41 | LG Electronics | Rel-16 | 80 |  |  |
| 2033 | 896 | Study on V2X Media Handling and Interaction |  | 525d? | 2017-09-08 A | 2019-09-12 A | 100% | finish no earlier than 2019-09-12 | S4 | 4200h | 4200h | FS_mV2X | 39 | Jung, Kyunghun, Samsung Electronics Co., Ltd | Rel-16 | 77 | kyunghun.jung@samsung.com |  |
| 2034 | 897 | Study on Security Aspects of 3GPP support for Advanced V2X Services |  | 265.88d | 2019-03-07 A | 2020-03-12 A | 100% | finish no earlier than 2020-03-12 | S3 | 2127h | 2127h | FS_eV2X_Sec | 42 | Joonwoong Kim, LG Electronics | Rel-16 | 83 | joonwoong.kim@lge.com |  |

Notes:
- 2004: RAN3 impact?¦16/1/19: WID:RP-181450->RP-182891¦26/3/19: WID:RP-182891->RP-190770; 26/6/19: WID:RP-190770->RP-191356; 14/1/20: WID:RP-191356->RP-192875
- 2005: RAN3 impact?¦26/3/19: WID:RP-182891->RP-190770; 28/7/20: 0%->100
- 2006: 26/3/19: WID:RP-182891->RP-190770; 6/1/21: 0%->100
- 2007: RAN3 impact?¦16/1/19: WID:RP-181451->RP-182902¦26/3/19: WID:RP-182902->RP-190757; 26/6/19: WID:RP-190757->RP-191576; 8/10/19: WID:RP-191576->RP-192313; 14/1/20: WID:RP-192313->RP-193224; 26/3/20: WID:RP-193224->RP-200293
- 2008: RAN3 impact?¦26/3/19: WID:RP-182902->RP-190757; 28/7/20: 0%->100
- 2009: 26/3/19: WID:RP-182902->RP-190757; 6/1/21: 0%->100
- 2010: Impacted TSs and TRs: 22.262
- 2011: 15/12/17: 22.824 added;¦15/12/17: 0%->25¦16/3/18: 25%->60¦10/9/18: 60%->95¦4/12/18: 95%->100 / Impacted TSs and TRs: New; 22.824
- 2012: 4/12/18: 0%->100 / Impacted TSs and TRs: 22.262; 22.261
- 2013: -
- 2014: 7/6/18: 0%->75¦10/9/18: 75%->95¦4/12/18: 95%->100 / Impacted TSs and TRs: 22.886
- 2015: 4/12/18: 0%->95¦14/3/19: 95%->100 / Impacted TSs and TRs: 22.186
- 2016: 7/12/18: 0%->25¦14/3/19: 25%->65 / Impacted TSs and TRs: New
- 2017: 16/3/18: 0%->45¦14/6/18: 45%->75¦10/9/18: 75%->95¦7/12/18: 95%->100
- 2018: 7/12/18: 0%->25¦14/3/19: 25%->65; 31/5/19: 65%->95; 13/9/19: 95%->100 / Impacted TSs and TRs: New
- 2019: 16/9/19: WID:CP-191153->CP-192077
- 2020: 13/9/19: 0%->10; 6/12/19: 10%->30; 26/3/20: 30%->65; 26/6/20: 65%->100 / Impacted TSs and TRs: 24.386; 27.007
- 2021: 13/9/19: 0%->10; 6/12/19: 10%->60; 26/3/20: 60%->100 / Impacted TSs and TRs: 29.122; 29.116
- 2022: 26/3/20: 0%->100 / Impacted TSs and TRs: 23.003; 23.008
- 2023: 14/3/19: 0%->30 / Impacted TSs and TRs: 23.501; 23.502; 23.503; 23.285
- 2024: 11/9/17: 0%->20¦15/12/17: Changed Rel-15->Rel-16¦16/3/18: WID:SP-170379->SP 170590¦16/3/18: 20%->25¦7/6/18: 25%->35¦10/9/18: 35%->58¦10/9/18: FCD:09/18->12/18¦2/10/18: WID:SP 170590->SP-180733¦7/12/18: 58%->88¦14/3/19: 88%->95; 31/5/19: 95%->100 / Impacted TSs and TRs: 23.786
- 2025: 14/3/19: 0%->30; 31/5/19: 30%->75; 26/6/19: 24.588 added;; 13/9/19: 75%->90; 6/12/19: 90%->96; 25/3/20: 96%->100 / Impacted TSs and TRs: 23.501; 23.502; 23.503; 23.285; 24.588
- 2026: 16/9/19: WID:CP-191154->CP-192078; 25/3/20: WID:CP-192078->CP-200291; 2/7/20: WID:CP-200291->CP-201343
- 2027: 13/9/19: 0%->30; 6/12/19: 30%->65; 26/3/20: 65%->95; 26/6/20: 95%->99; 13/9/20: 99%->100 / Impacted TSs and TRs: 23.122; 24.501; 24.301; 27.007
- 2028: 13/9/19: 0%->30; 6/12/19: 30%->80; 26/3/20: 80%->90; 26/6/20: 90%->100; 26/6/20: WID:CP-200291->CP-201199 / Impacted TSs and TRs: 29.512; 29.513; 29.514; 29.519; 29.122; 29.522
- 2029: 26/3/20: 0%->95; 26/6/20: 95%->100 / Impacted TSs and TRs: 23.003; 23.008; 29.502; 29.503; 29.505; 29.510; 29.518; 29.527; 29.571
- 2030: 26/3/20: 0%->100 / Impacted TSs and TRs: 31.102
- 2031: ; 6/12/19: 0%->10; 25/3/20: 10%->70; 26/6/20: 70%->95; 12/9/20: 95%->98; 5/12/20: 98%->99; 19/3/21: 99%->100 / Impacted TSs and TRs: 33.220; TS 33.536
- 2032: TR 38.8XX¦compare SA1 REL-15 SI FS_eV2X, RAN1 REL-15 SI FS_LTE_NR_V2X_eval, SA2 REL-16 SI FS_eV2XARC, SA1 REL-16 SI FS_V2XIMP¦26/3/19: WID:RP-181480->RP-190224¦26/3/19: 0%->100
- 2033: 15/12/17: 26.985 added;¦15/12/17: 0%->30¦16/3/18: 30%->50¦22/3/18: FCD:09/18->12/18¦7/6/18: 50%->60. 14/06/18: Moved from Rel-15¦10/9/18: 60%->80¦13/12/18: 80%->60¦13/12/18: FCD:12/18->09/19¦12/3/19: 60%->70; 31/5/19: 70%->80; 26/6/20: 80%->100 / Impacted TSs and TRs: New; 26.985
- 2034: 31/5/19: 0%->20; 13/9/19: 20%->60; 13/9/19: FCD:05/09/2019->12/20; 6/12/19: 60%->75; 6/12/19: FCD:12/12/2019->03/20; 26/6/20: 75%->100 / Impacted TSs and TRs: New

| ID | WBS | Task | Type | Duration | Start | Finish | Complete | Remaining | Total slack | Constraint | Resources | Work | Actual work | Acronym | PCG approved | WI rapporteur name | Release | TSG approved | WI rapporteur e-mail | Status Report | Impacted TSs and TRs |
| --- | --- | --- | --- | --- | --- | --- | --- | --- | --- | --- | --- | --- | --- | --- | --- | --- | --- | --- | --- | --- | --- |
| 2035 | 898 | **5G V2X with NR sidelink** |  | 1379d | 2019-03-01 A | 2024-06-06 | 79% | 294.35d | 453d |  | R1 | 24648h | 9918h | 5G_V2X_NRSL | 42 | LG Electronics | Rel-16 | 83 |  |  |  |
| 2036 | 898.1 | Core part: 5G V2X with NR sidelink |  | 261d | 2019-03-01 A | 2020-02-28 A | 100% |  |  | finish no earlier than 2020-03-01 | R1 | 2088h | 2088h | 5G_V2X_NRSL-Core | 42 | LG Electronics | Rel-16 | 83 |  |  |  |
| 2037 | 898.2 | Perf. part: 5G V2X with NR sidelink |  | 403d | 2019-03-01 A | 2020-09-15 A | 100% |  |  | finish no earlier than 2020-09-15 | R4 | 3224h | 3224h | 5G_V2X_NRSL-Perf | 42 | LG Electronics | Rel-16 | 83 |  |  |  |
| 2038 | 898.3 | UE Conformance Test Aspects - 5G V2X with NR sidelink |  | 1038d | 2020-06-22 A | 2024-06-06 | 65% | 363.3d | 453d | finish no earlier than 2024-06-06 | R5 | 8304h |  | 5G_V2X_NRSL_eV2XARC-UEConTest | 45 | Xuesong Wang, Huawei Technologies. Co., Ltd | Rel-16 | 88 | wangxuesong743@huawei.com | RP-240276 |  |
| 2039 | 899 | 5G Location and Positionning Services | milestone | 0d? | 2017-06-05 A | 2017-06-05 A | 100% |  |  |  |  |  |  |  |  |  | Rel-16 |  |  |  |  |
| 2040 | 900 | **5G positioning services** |  | 400d? | 2017-06-05 A | 2018-12-14 A | 100% |  |  |  | S1 | 6464h | 6464h | 5G_HYPOS | 41 | Ries, Lionel, ESA | Rel-16 | 80 | lionel.ries at esa.int |  | 22.261 |
| 2041 | 900.1 | Study on positioning use cases |  | 270d? | 2017-06-05 A | 2018-06-15 A | 100% |  |  | finish no earlier than 2018-06-15 | S1 | 2160h | 2160h | FS_5G_HYPOS | 39 | Ries, Lionel, ESA | Rel-16 | 76 | lionel.ries@esa.int |  | 22.872 |
| 2042 | 900.2 | Stage 1 of 5G_HYPOS |  | 138d? | 2018-06-06 A | 2018-12-14 A | 100% |  |  | finish no earlier than 2018-12-14 | S1 | 1104h | 1104h | 5G_HYPOS | 41 | Ries, Lionel, ESA | Rel-16 | 80 | lionel.ries at esa.int |  | 22.261 |
| 2043 | 901 | **Enhancement to the 5GC LoCation Services** |  | 651d? | 2017-12-15 A | 2020-06-12 | 98% | 12.17d? | 1496d |  |  | 14152h | 12505.6h | 5G_eLCS | 42 | Ming Ai, CATT | Rel-16 | 83 | aiming@catt.cn |  | 23.501; 23.502 |
| 2044 | 901.1 | Study on Enhancement to the 5GC Location Services |  | 325d? | 2017-12-15 A | 2019-03-14 A | 100% |  |  | finish no earlier than 2019-03-14 | S2 | 2600h | 2600h | FS_eLCS | 40 | Ming Ai, CATT | Rel-16 | 78 | aiming@catt.cn |  | new 23.731 |
| 2045 | 901.2 | Study on Security of the enhancement to the 5GC location services |  | 332d? | 2018-09-06 A | 2019-12-13 A | 100% |  |  | finish no earlier than 2019-12-13 | S3 | 2656h | 2656h | FS_eLCS_Sec | 41 | Wei Zhou, CATT | Rel-16 | 81 | zhouwei@catt.cn |  | New |
| 2046 | 901.3 | Stage 2 of 5G_eLCS |  | 136d | 2018-12-13 A | 2019-06-20 A | 100% |  |  | start no earlier than 2018-12-13 | S2 | 1088h | 1088h | 5G_eLCS | 42 | Ming Ai, CATT | Rel-16 | 82 | aiming@catt.cn |  | 23.501; 23.502; 29.515 |
| 2047 | 901.4 | **CT aspects of 5G_eLCS** |  | 196d | 2019-03-07 A | 2019-12-05 | 95% | 9.8d | 1632d |  | ct | 6272h | 4625.61h | 5G_eLCS | 42 | Tingfang Tang, CATT | Rel-16 | 83 | tangtingfang@catt.cn |  |  |
| 2048 | 901.4.1 | CT1 aspects of 5G_eLCS |  | 196d | 2019-03-07 A | 2019-12-05 A | 100% |  |  | start no earlier than 2019-03-07 | C1 | 1568h | 1568h | 5G_eLCS | 42 | Tingfang Tang, CATT | Rel-16 | 83 | tangtingfang@catt.cn |  | 24.501; 27.007 |
| 2049 | 901.4.2 | CT3 aspects of 5G_eLCS |  | 196d | 2019-03-07 A | 2019-12-05 | 85% | 29.4d | 1632d | start no earlier than 2019-03-07 | C3 | 1568h |  | 5G_eLCS | 42 | Tingfang Tang, CATT | Rel-16 | 83 | tangtingfang@catt.cn |  | 29.522; 29.122 |
| 2050 | 901.4.3 | CT4 aspects of 5G_eLCS |  | 196d | 2019-03-07 A | 2019-12-05 A | 100% |  |  | start no earlier than 2019-03-07 | C4 | 1568h | 1568h | 5G_eLCS | 42 | Tingfang Tang, CATT | Rel-16 | 83 | tangtingfang@catt.cn |  | 24.080; 29.518; 29.572; 29.503; 29.505 |
| 2051 | 901.5 | Security of 5G_eLCS |  | 192d | 2019-09-19 A | 2020-06-12 A | 100% |  |  | finish no earlier than 2020-06-12 | S3 | 1536h | 1536h | 5G_eLCS | 43 | Wei Zhou, CATT | Rel-16 | 85 | zhouwei@catt.cn |  | 33.501 |
| 2052 | 902 | **NR positioning support** |  | 1367d? | 2018-06-15 A | 2023-09-08 | 99% | 0d? | 0d |  | R1 | 25192h | 17181.7h | NR_pos | 42 | Intel | Rel-16 | 83 |  |  |  |
| 2053 | 902.1 | Study on NR positioning support |  | 196d? | 2018-06-15 A | 2019-03-15 A | 100% |  |  | finish no earlier than 2019-03-15 | R1 | 1568h | 1568h | FS_NR_pos | 41 | Intel | Rel-16 | 80 |  |  |  |
| 2054 | 902.2 | Study on local NR positioning in NG-RAN |  | 206d | 2019-03-01 A | 2019-12-13 A | 100% |  |  | finish no earlier than 2019-12-15 | R3 | 1648h | 1648h | FS_NR_local_pos | 42 | CMCC | Rel-16 | 83 |  |  | 38.856 |
| 2055 | 902.3 | Core part: NR positioning support |  | 261d | 2019-03-01 A | 2020-02-28 A | 100% |  |  | finish no earlier than 2020-03-01 | R1 | 2088h | 2088h | NR_pos-Core | 42 | Intel | Rel-16 | 83 |  |  |  |
| 2056 | 902.4 | Perf. part: NR positioning support |  | 403d | 2019-03-01 A | 2020-09-15 A | 100% |  |  | finish no earlier than 2020-09-15 | R4 | 3224h | 3224h | NR_pos-Perf | 42 | Intel | Rel-16 | 83 |  |  |  |
| 2057 | 902.5 | UE Conformance Test Aspects - NR positioning support |  | 716d | 2020-12-14 A | 2023-09-08 A | 100% |  |  | finish no earlier than 2023-09-08 | R5 | 5728h | 5728h | NR_pos-UEConTest | 46 | Xiaoyang TIAN, CATT | Rel-16 | 90 | tianxiaoyang@catt.cn | RP-231835 |  |
| 2058 | 903 | UE radio capability signalling optimization | milestone | 0d? | 2018-06-06 A | 2018-06-06 A | 100% |  |  |  |  |  |  |  |  |  | Rel-16 |  |  |  |  |

Notes:
- 2035: 26/6/19: WID:RP-190766->RP-190984; 8/10/19: WID:RP-190984->RP-191723; 26/3/20: WID:RP-191723->RP-200129
- 2036: 28/7/20: 0%->100
- 2037: 2/7/21: 0%->100
- 2038: 8/10/20: 0%->5; 8/4/21: 5%->11; 2/7/21: 11%->18; 22/3/22: Compl:18%->43%; ; 5/4/22: WID:RP-200894->RP-220744 20/6/22: Rapporteur: Huawei->Xuesong Wang, Huawei Technologies. Co., Ltd; Rap eMail: ->wangxuesong743@huawei.com12/7/22: WID:RP-20089...; 9/1...; 14/3/24: FCD:05/06/2024->06/06/2024; Compl:63%->65%; Stat Rep: RP-233757->RP-240276;
- 2039: -
- 2041: 11/9/17: 0%->10¦15/12/17: 10%->50¦15/12/17: FCD:03/18->06/18¦16/3/18: 50%->75¦7/6/18: 75%->90¦10/9/18: 90%->100
- 2042: 10/9/18: 0%->50¦10/9/18: FCD:09/18->12/18¦4/12/18: 50%->100
- 2044: 16/3/18: 0%->15¦7/6/18: 15%->45¦10/9/18: 45%->55¦10/9/18: FCD:12/18->03/19¦2/10/18: WID:SP-170937->SP-180734¦7/12/18: 55%->100
- 2045: 7/12/18: 0%->5¦20/3/19: 5%->50; 31/5/19: 50%->80; 13/9/19: 80%->100
- 2046: 14/3/19: 0%->45; 31/5/19: 45%->85; 26/6/19: 29.515 added;; 13/9/19: 85%->100
- 2047: 17/9/19: WID:CP-190014->CP-192260
- 2048: 3/6/19: WID:CP-190190->CP-191064; 13/9/19: 0%->40; 6/12/19: 40%->90; 26/6/20: 90%->99; 13/9/20: 99%->100
- 2049: 3/6/19: WID:CP-190190->CP-191064; 26/3/20: 0%->25; 26/6/20: 25%->85
- 2050: 31/5/19: 0%->10; 3/6/19: WID:CP-190190->CP-191064; 13/9/19: 10%->20; 6/12/19: 20%->90; 26/3/20: 90%->98; 26/6/20: 98%->100
- 2051: ; 6/12/19: 0%->75; 6/12/19: FCD:12/12/2019->03/20; 25/3/20: FCD:12/03/2020->06/20; 26/6/20: 75%->100
- 2052: 26/6/19: WID:RP-190752->RP-191156; 14/1/20: WID:RP-191156->RP-192581
- 2053: TR 38.8xx¦26/3/19: 0%->100
- 2054: 8/10/19: WID:RP-190754->RP-191774; 8/10/19: 38.856 added;; 14/1/20: 0%->100
- 2055: 25/9/20: 0%->100
- 2056: 2/7/21: 0%->100
- 2057: tested: REL-16 WI NR_pos-Core ; 8/4/21: 0%->5; 29/9/21: WID:RP-202727->RP-212227; 22/3/22: Compl:5%->54%; ; 20/6/22: Rapporteur: CATT->Xiaoyang TIAN, CATT; Rap eMail: ->tianxiaoyang@catt.cn12/7/22: WID:RP-212227->RP-221450 ; ;...; 9/12/22: FCD:22/12...; 6/9/23: FCD:09/09/2023->08/09/2023; Compl:95%->100%; Stat Rep: RP-230393->RP-231835;
- 2058: -

| ID | WBS | Task | Type | Duration | Start | Finish | Complete | Remaining | Total slack | Constraint | Resources | Work | Actual work | Acronym | PCG approved | Impacted TSs and TRs | WI rapporteur name | WI rapporteur e-mail | Release | TSG approved | Status Report |
| --- | --- | --- | --- | --- | --- | --- | --- | --- | --- | --- | --- | --- | --- | --- | --- | --- | --- | --- | --- | --- | --- |
| 2059 | 904 | **Optimisations on UE radio capability signalling** |  | 462d? | 2018-06-06 A | 2020-03-12 A | 100% |  |  |  |  | 8063h | 8063h | RACS | 43 | 23.501; 23.502; 23.401 | Haris Zisimopoulos | harisz@qti.qualcomm.com | Rel-16 | 84 |  |
| 2060 | 904.1 | Study on RACS |  | 138d? | 2018-06-06 A | 2018-12-14 A | 100% |  |  | finish no earlier than 2018-12-14 | S2 | 1104h | 1104h | FS_RACS | 41 | New | Haris Zisimopoulos, Qualcomm Incorporated | harisz@qti.qualcomm.com | Rel-16 | 80 |  |
| 2061 | 904.2 | Stage 2 of RACS |  | 65.88d | 2019-03-07 A | 2019-06-06 A | 100% |  |  |  | S2 | 527h | 527h | RACS | 42 | 23.501; 23.502; 23.401; 29.673 | Haris Zisimopoulos | harisz@qti.qualcomm.com | Rel-16 | 83 |  |
| 2062 | 904.3 | **CT aspects of RACS** |  | 201d | 2019-06-06 A | 2020-03-12 A | 100% |  |  |  | ct | 6432h | 6432h | RACS | 43 |  | Waqar Zia; Qualcomm Incorporated | wzia@qti.qualcomm.com | Rel-16 | 84 |  |
| 2063 | 904.3.1 | CT1 aspects of RACS |  | 201d | 2019-06-06 A | 2020-03-12 A | 100% |  |  | finish no earlier than 2020-03-12 | C1 | 1608h | 1608h | RACS | 43 | 24.301; 24.501; 24.368; 27.007 | Waqar Zia; Qualcomm Incorporated | wzia@qti.qualcomm.com | Rel-16 | 84 |  |
| 2064 | 904.3.2 | CT3 aspects of RACS |  | 201d | 2019-06-06 A | 2020-03-12 A | 100% |  |  | finish no earlier than 2020-03-12 | C3 | 1608h | 1608h | RACS | 43 | 29.122; 29.522 | Waqar Zia; Qualcomm Incorporated | wzia@qti.qualcomm.com | Rel-16 | 84 |  |
| 2065 | 904.3.3 | CT4 aspects of RACS |  | 201d | 2019-06-06 A | 2020-03-12 A | 100% |  |  | finish no earlier than 2020-03-12 | C4 | 1608h | 1608h | RACS | 43 | 23.003; 23.008; 29.230; 29.274; 29.510; 29.518 | Waqar Zia; Qualcomm Incorporated | wzia@qti.qualcomm.com | Rel-16 | 84 |  |
| 2066 | 905 | **Optimisations on UE radio capability signalling – NR/E-UTRA Aspects** |  | 1232d? | 2018-06-15 A | 2023-03-03 | 99% | 0d? | 0d |  | R2 | 19664h | 11358.9h | RACS-RAN | 42 |  | MediaTek |  | Rel-16 | 83 |  |
| 2067 | 905.1 | Study on optimisations on UE radio capability signalling – NR/E-UTRA Aspects |  | 196d? | 2018-06-15 A | 2019-03-15 A | 100% |  |  | finish no earlier than 2019-03-15 | R2 | 1568h | 1568h | FS_RACS_RAN | 41 | 37.873 | MediaTek |  | Rel-16 | 80 |  |
| 2068 | 905.2 | Core part: Optimisations on UE radio capability signalling – NR/E-UTRA Aspects |  | 261d | 2019-03-01 A | 2020-02-28 A | 100% |  |  | finish no earlier than 2020-03-01 | R2 | 2088h | 2088h | RACS-RAN-Core | 42 |  | MediaTek |  | Rel-16 | 83 |  |
| 2069 | 905.3 | UE Conformance Test Aspects - Optimisations on UE radio capability signalling - NR/E-UTRA Aspects |  | 772d | 2020-03-19 A | 2023-03-03 A | 100% |  |  | finish no earlier than 2023-03-03 | R5 | 6176h | 6176h | RACS-UEConTest | 45 |  | Yogesh Tugnawat, Qualcomm | yogesht[at]qti.qualcomm.com | Rel-16 | 88 | RP-230098 |
| 2070 | 906 | Study on solutions for NR to support non-terrestrial networks (NTN) |  | 391d? | 2018-06-15 A | 2019-12-13 A | 100% |  |  | finish no earlier than 2019-12-15 | R3 | 3128h | 3128h | FS_NR_NTN_solutions | 41 | 38.821 | Thales |  | Rel-16 | 80 |  |
| 2071 | 907 | Enablers for Network Automation Architecture for 5G |  | 1d? | 2017-06-05 A | 2017-06-05 A | 100% |  |  | finish no earlier than 2017-06-05 |  |  |  |  |  |  |  |  | Rel-16 |  |  |
| 2072 | 908 | **Enablers for Network Automation for 5G** |  | 724d? | 2017-06-05 A | 2020-03-12 A | 100% |  |  |  |  | 10128h | 10128h | eNA | 42 | 23.501; 23.502; 23.503 | Xiaobo Wu, Huawei Technologies | wuxiaobo@huawei.com | Rel-16 | 83 |  |
| 2073 | 908.1 | Study of enablers for Network Automation for 5G |  | 400d? | 2017-06-05 A | 2018-12-14 A | 100% |  |  | finish no earlier than 2018-12-14 | S2 | 3200h | 3200h | FS_eNA | 39 | new 23.791 | Xiaobo Wu, Huawei Technologies | wuxiaobo@huawei.com | Rel-16 | 76 |  |
| 2074 | 908.2 | Stage 2 of eNA |  | 138d | 2018-12-06 A | 2019-06-17 A | 100% |  |  | start no earlier than 2018-12-06 | S2 | 1104h | 1104h | eNA | 42 | 23.501; 23.502; 23.503; 29.517 | Xiaobo Wu, Huawei Technologies | wuxiaobo@huawei.com | Rel-16 | 82 |  |
| 2075 | 908.3 | **CT aspects of eNA** |  | 266d | 2019-03-07 A | 2020-03-12 A | 100% |  |  |  | ct | 5824h | 5824h | eNA | 42 |  | Yali Yan, Huawei | yanyali@huawei.com | Rel-16 | 83 |  |
| 2076 | 908.3.1 | CT3 aspects of eNA |  | 266d | 2019-03-07 A | 2020-03-12 A | 100% |  |  | finish no earlier than 2020-03-12 | C3 | 2128h | 2128h | eNA | 42 | 29.122; 29.508; 29.514; 29.520; 29.522; 29.523; 29.554 | Yali Yan, Huawei | yanyali@huawei.com | Rel-16 | 83 |  |
| 2077 | 908.3.2 | CT4 aspects of eNA |  | 196d | 2019-03-07 A | 2019-12-05 A | 100% |  |  |  | C4 | 1568h | 1568h | eNA | 42 | 29.244; 29.510; 29.518; 29.503; 29.505 | Yali Yan, Huawei | yanyali@huawei.com | Rel-16 | 83 |  |
| 2078 | 909 | Wireless and Wireline Convergence Enhancement | milestone | 0d? | 2017-06-05 A | 2017-06-05 A | 100% |  |  |  |  |  |  |  |  |  |  |  | Rel-16 |  |  |
| 2079 | 910 | Study on the Wireless and Wireline Convergence for the 5G system architecture |  | 400d? | 2017-06-05 A | 2018-12-14 A | 100% |  |  | finish no earlier than 2018-12-14 | S2 | 3200h | 3200h | FS_5WWC | 39 | 23.716 | Marco Spini, Huawei Technologies | m.spini@huawei.com | Rel-16 | 76 |  |
| 2080 | 911 | Study on the security of the Wireless and Wireline Convergence for the 5G system architecture |  | 332d? | 2018-06-06 A | 2019-09-12 A | 100% |  |  | finish no earlier than 2019-09-12 | S3 | 2656h | 2656h | FS_5WWC_SEC | 41 | New; 33.807 | He Li, Huawei Technologies | LIHE2@HUAWEI.COM | Rel-16 | 80 |  |
| 2081 | 912 | **Wireless and Wireline Convergence for the 5G system architecture** |  | 397d | 2018-12-06 A | 2020-06-12 A | 100% |  |  |  |  | 14432h | 14432h | 5WWC | 42 | 23.501; 23.502; 23.503 | Marco Spini, Huawei Technologies | m.spini@huawei.com | Rel-16 | 83 |  |
| 2082 | 912.1 | Stage 2 of 5WWC |  | 136d | 2018-12-06 A | 2019-06-13 A | 100% |  |  |  | S2 | 1088h | 1088h | 5WWC | 42 | 23.501; 23.502; 23.503 | Marco Spini, Huawei Technologies | m.spini@huawei.com | Rel-16 | 82 |  |

Notes:
- 2059: 26/6/19: WID:SP-190180->RP-191460
- 2060: 10/9/18: 0%->40¦7/12/18: 40%->70¦14/3/19: 70%->100
- 2061: 31/5/19: 0%->90; 26/6/19: 29.673 added;; 13/9/19: 90%->100
- 2062: 17/9/19: WID:CP-191061->CP-192207; 25/3/20: WID:CP-192207->CP-200058
- 2063: 13/9/19: 0%->50; 6/12/19: 50%->80; 26/3/20: 80%->100
- 2064: 13/9/19: 0%->50; 6/12/19: 50%->90; 26/3/20: 90%->100
- 2065: 13/9/19: 0%->20; 6/12/19: 20%->75; 26/3/20: 75%->90; 26/6/20: 90%->100
- 2066: 26/3/20: WID:RP-190657->RP-200164
- 2067: TR 37.873¦related SA2 SI FS_RACS was started at SA #80 ¦6/8/18: 37.873 added;¦26/3/19: 0%->100
- 2068: 26/6/19: WID:RP-190657->RP-191088; 28/7/20: 0%->100
- 2069: 8/10/20: 0%->5; 7/4/21: WID:RP-201153->RP-210714; 8/4/21: 5%->25; 8/4/21: FCD:19/03/2021->09/21; 2/7/21: 25%->50; 22/3/22: ; 5/4/22: WID:RP-210714->RP-220434 ; 9/12/22: Acronym:RACS-UEConTest->NG_RAN_PRN_Vertical_LAN-UEConTest; FCD:22/12/2022->01/03...
- 2070: TR 38.xx1¦compare REL-15 SI FS_NR_nonterr_nw¦26/3/19: WID:RP-181370->RP-190710; 14/1/20: 0%->100
- 2071: -
- 2073: 16/3/18: FCD:09/18->06/18¦16/3/18: 0%->15¦7/6/18: 15%->30¦15/6/18: WID:SP-170383->SP-180613¦15/6/18: FCD:06/18->09/18¦10/9/18: 30%->50¦10/9/18: FCD:09/18->12/18¦2/10/18: WID:SP-180613->SP-180792¦7/12/18: 50%->90¦14/3/19: 90%->94; 31/5/19: 94%->100
- 2074: 14/3/19: 0%->50; 31/5/19: 50%->85; 26/6/19: 29.517 added;; 13/9/19: 85%->92; 6/12/19: 92%->97; 25/3/20: 97%->100
- 2075: 3/6/19: WID:CP-190194->CP-191111; 17/9/19: WID:CP-191111->CP-192259
- 2076: 31/5/19: 0%->20; 3/6/19: WID:CP-190194->CP-191111; 13/9/19: 20%->55; 6/12/19: 55%->85; 6/12/19: FCD:05/12/2019->03/20; 26/3/20: 85%->100
- 2077: 31/5/19: 0%->20; 3/6/19: WID:CP-190194->CP-191111; 13/9/19: 20%->25; 6/12/19: 25%->90; 26/3/20: 90%->100
- 2078: -
- 2079: 11/9/17: 0%->15¦15/12/17: Changed Rel-15->Rel-16¦16/3/18: 15%->25¦7/6/18: 25%->35¦10/9/18: 35%->60¦10/9/18: FCD:06/18->12/18¦7/12/18: 60%->100
- 2080: 6/8/18: 33.807 added;¦10/9/18: 0%->5¦7/12/18: 5%->30¦20/3/19: 30%->60¦20/3/19: FCD:019->09/19; 31/5/19: 60%->75; 8/10/19: 75%->100
- 2082: 14/3/19: 0%->50; 31/5/19: 50%->85; 13/9/19: 85%->100

| ID | WBS | Task | Duration | Start | Finish | Complete | Remaining | Total slack | Constraint | Resources | Work | Actual work | Acronym | PCG approved | WI rapporteur name | WI rapporteur e-mail | Release | TSG approved | Status Report |
| --- | --- | --- | --- | --- | --- | --- | --- | --- | --- | --- | --- | --- | --- | --- | --- | --- | --- | --- | --- |
| 2083 | 912.2 | **CT aspects of 5WWC** | 266d | 2019-03-07 A | 2020-03-12 A | 100% |  |  |  | ct | 7952h | 7952h | 5WWC | 42 | Herrero Veron, Christian (Huawei) | Christian.Herrero at huawei.com | Rel-16 | 83 |  |
| 2084 | 912.2.1 | CT1 aspects of 5WWC | 266d | 2019-03-07 A | 2020-03-12 A | 100% |  |  | finish no earlier than 2020-03-12 | C1 | 2128h | 2128h | 5WWC | 42 | Herrero Veron, Christian (Huawei) | Christian.Herrero at huawei.com | Rel-16 | 82 |  |
| 2085 | 912.2.2 | CT3 aspects of 5WWC | 266d | 2019-03-07 A | 2020-03-12 A | 100% |  |  | finish no earlier than 2020-03-12 | C3 | 2128h | 2128h | 5WWC | 42 | Herrero Veron, Christian (Huawei) | Christian.Herrero at huawei.com | Rel-16 | 82 |  |
| 2086 | 912.2.3 | CT4 aspects of 5WWC | 196d | 2019-06-13 A | 2020-03-12 A | 100% |  |  | finish no earlier than 2020-03-12 | C4 | 1568h | 1568h | 5WWC | 42 | Herrero Veron, Christian (Huawei) | Christian.Herrero at huawei.com | Rel-16 | 82 |  |
| 2087 | 912.3 | Security of 5WWC | 192d | 2019-09-19 A | 2020-06-12 A | 100% |  |  | finish no earlier than 2020-06-12 | S3 | 1536h | 1536h | 5WWC | 43 | He Li, Huawei Technologies | lihe2@huawei.com | Rel-16 | 85 |  |
| 2088 | 912.4 | Charging Aspect for 5WWC | 70d | 2019-12-06 A | 2020-03-12 A | 100% |  |  | finish no earlier than 2020-03-12 | S5 | 560h | 560h | 5WWC | 44 | ZHU, Lei, Huawei | lei.zhu@huawei.com | Rel-16 | 86 |  |
| 2089 | 912.5 | **NG interface usage for WWC** | 206d | 2019-03-01 A | 2019-12-13 A | 100% |  |  |  | R3 | 3296h | 3296h | 5WWC-NG_interface | 42 | Huawei |  | Rel-16 | 83 |  |
| 2090 | 912.5.1 | Core part: NG interface usage for WWC | 206d | 2019-03-01 A | 2019-12-13 A | 100% |  |  | finish no earlier than 2019-12-15 | R3 | 1648h | 1648h | 5WWC-NG_interface-Core | 42 | Huawei |  | Rel-16 | 83 |  |
| 2091 | 913 | Mission Critical, Public Warning, Railways and Maritime | 1d? | 2016-09-19 A | 2016-09-19 A | 100% |  |  |  |  |  |  |  |  |  |  | Rel-16 |  |  |
| 2092 | 914 | Study on MC services access aspects | 325d? | 2018-03-15 A | 2019-06-12 A | 100% |  |  | finish no earlier than 2019-06-12 | S6 | 2600h | 2600h | FS_MCSAA | 40 | Joakim Åkesson, Ericsson | Joakim.akesson@ericsson.com | Rel-16 | 79 |  |
| 2093 | 915 | Study into discreet listening and logging for mission critical services | 266d? | 2018-06-06 A | 2019-06-12 A | 100% |  |  | finish no earlier than 2019-06-12 | S6 | 2128h | 2128h | FS_MCLOG | 41 | Chater-Lea, David, Motorola Solutions | david.chater-lea@motorolasolutions.com | Rel-16 | 80 |  |
| 2094 | 916 | **Enhanced Mission Critical Push-to-talk architecture phase 2** | 70d | 2019-12-06 A | 2020-03-12 A | 100% |  |  |  | S6 | 1680h | 1680h | enh2MCPTT | 41 | Dom Lazara; Motorola Solutions | Dom.Lazara@motorolasolutions.com | Rel-16 | 80 |  |
| 2095 | 916.1 | Stage 2 of enh2MCPTT | 70d | 2019-12-06 A | 2020-03-12 A | 100% |  |  |  | S6 | 560h | 560h | enh2MCPTT | 41 | Dom Lazara; Motorola Solutions | Dom.Lazara@motorolasolutions.com | Rel-16 | 80 |  |
| 2096 | 916.2 | CT aspects of enh2MCPTT | 70d | 2019-12-06 A | 2020-03-12 A | 100% |  |  | finish no earlier than 2020-03-12 | C1 | 560h | 560h | enh2MCPTT-CT | 44 | Mike Dolan, FirstNet | michael.dolan@firstnet.gov | Rel-16 | 86 |  |
| 2097 | 917 | **Enhancements to Functional architecture and information flows for Mission Critical Data** | 462d? | 2018-06-06 A | 2020-03-12 A | 100% |  |  |  | S6 | 7928h | 7928h | eMCData2 | 42 | Shih, Jerry, AT&T | jerry.shih@att.com | Rel-16 | 83 |  |
| 2098 | 917.1 | Stage 2 of eMCData2 | 268d? | 2018-06-06 A | 2019-06-14 A | 100% |  |  | finish no earlier than 2019-06-14 | S6 | 2144h | 2144h | eMCData2 | 41 | Shih, Jerry, AT&T | jerry.shih@att.com | Rel-16 | 80 |  |
| 2099 | 917.2 | CT aspects of eMCData2 | 261d? | 2019-03-14 A | 2020-03-12 A | 100% |  |  | finish no earlier than 2020-03-12 | C1 | 2088h | 2088h | eMCData2 | 42 | Val Oprescu (AT&T) | vo4887@att.com | Rel-16 | 83 |  |
| 2100 | 918 | **MCData File Distribution support over xMB** | 396d? | 2018-09-06 A | 2020-03-12 A | 100% |  |  |  |  | 2584h | 2584h | MC_XMB | 43 | Thiénot Cédric, Expway | cedric.thienot@expway.com | Rel-16 | 85 |  |
| 2101 | 918.1 | Stage 2 of MC_XMB | 197d? | 2018-09-06 A | 2019-06-07 A | 100% |  |  | finish no earlier than 2019-06-07 | S4 | 1576h | 1576h | MC_XMB | 41 | Thiénot Cédric, Expway | cedric.thienot@expway.com | Rel-16 | 81 |  |
| 2102 | 918.2 | CT aspects of MC_XMB | 126d | 2019-09-19 A | 2020-03-12 A | 100% |  |  | finish no earlier than 2020-03-12 | C3 | 1008h | 1008h | MC_XMB-CT | 43 | Wenliang Xu, Ericsson | wenliang.xu@ericsson.com | Rel-16 | 85 |  |
| 2103 | 919 | Protocol enhancements for Mission Critical Services | 337d? | 2018-09-06 A | 2019-12-20 A | 100% |  |  | finish no earlier than 2019-12-20 | C1 | 2696h | 2696h | MCProtoc16 | 41 | AXELL, Jörgen | jorgen.axell@ericsson.com | Rel-16 | 81 |  |
| 2104 | 920 | Conformance Test Aspects - Protocol enhancements for Mission Critical Services for Rel-16 (MCPTT, MCVideo, MCData) | 526d | 2022-09-08 A | 2024-09-09 | 67% | 173.58d | 386d | finish no earlier than 2024-09-09 | R5 | 4208h |  | MCProtoc16_enh2MCPTT_eMCData2-ConTest | 49 | Jason Kahn, NIST | jason.kahn@nist.gov | Rel-16 | 97 | RP-240105 |
| 2105 | 921 | **MBMS APIs for Mission Critical Services** | 464d? | 2017-06-05 A | 2019-03-14 A | 100% |  |  |  | S6 | 7488h | 7488h | MBMSAPI_MCS | 41 | Ling Zhang, TD Tech Ltd. | zhangling@td-tech.com | Rel-16 | 80 |  |
| 2106 | 921.1 | Study on MBMS APIs for MC Services | 270d? | 2017-06-05 A | 2018-06-15 A | 100% |  |  | finish no earlier than 2018-06-15 | S6 | 2160h | 2160h | FS_MBMSAPI_MC | 39 | Ling Zhang, TD Tech Ltd | zhangling@td-tech.com | Rel-16 | 76 |  |
| 2107 | 921.2 | Stage 2 of MBMS APIs for MC Services | 202d? | 2018-06-06 A | 2019-03-14 A | 100% |  |  | finish no earlier than 2019-03-14 | S6 | 1616h | 1616h | MBMSAPI_MCS | 41 | Ling Zhang, TD Tech Ltd. | zhangling@td-tech.com | Rel-16 | 80 |  |

Notes:
- 2083: 3/6/19: WID:CP-190200->CP-191156. Confusion with UID (was 829910 instead of 830015); 17/9/19: WID:CP-191156->CP-192079; 9/12/19: WID:CP-192079->CP-193145; 2/7/20: WID:CP-193145->CP-192079
- 2084: 31/5/19: 0%->30; 3/6/19: WID:CP-190200->CP-191156; 3/6/19: FCD:05/12/2019->03/20; 13/9/19: 30%->60; 6/12/19: 60%->80; 26/3/20: 80%->95; 30/6/20: 95%->100 / Impacted TSs and TRs: 24.501; 24.502; 24.526
- 2085: 31/5/19: 0%->15; 3/6/19: WID:CP-190200->CP-191156; 3/6/19: FCD:05/12/2019->03/20; 13/9/19: 15%->50; 6/12/19: 50%->70; 6/12/19: WID:CP-192079->CP-193145; 26/3/20: 70%->95; 26/6/20: 95%->100 / Impacted TSs and TRs: 29.512; 29.513; 29.514; 29.507; 29.122; 29.522
- 2086: 3/6/19: WID:CP-190200->CP-191156; 3/6/19: FCD:05/12/2019->03/20; 13/9/19: 0%->5; 6/12/19: 5%->60; 26/3/20: 60%->95; 26/6/20: 95%->100 / Impacted TSs and TRs: 23.003; 29.518; 29.502; 29.509; 29.244; 29.503; 29.571; 29.505
- 2087: 13/9/19: 0%->100; 8/10/19: 100%->0; 6/12/19: 0%->90; 6/12/19: FCD:12/12/2019->03/20; 25/3/20: FCD:12/03/2020->06/20; 25/3/20: 90%->95; 26/6/20: 95%->100 / Impacted TSs and TRs: 33.501
- 2088: ; 26/3/20: 0%->35; 28/6/20: 35%->100 / Impacted TSs and TRs: 32.240; 32.255; 32.291; 32.298
- 2090: 26/6/19: WID:RP-190772->RP-190999; 28/7/20: 0%->100
- 2091: -
- 2092: 19/4/18: 0%->5¦14/6/18: 5%->15¦15/6/18: WID:SP-180163->SP-180385¦15/6/18: FCD:12/18->03/19¦6/8/18: 23.778 added;¦10/9/18: 15%->25¦7/12/18: 25%->70¦14/12/18: WID:SP-180385->SP-181135¦14/3/19: FCD:03/19->06/19¦14/3/19: 70%->75; 31/5/19: 75%->100 / Impacted TSs and TRs: new 23.xxx; 23.778
- 2093: 6/8/18: 23.784 added;¦10/9/18: 0%->10¦7/12/18: 10%->50¦7/12/18: FCD:03/19->06/19¦14/12/18: WID:SP-180384->SP-181138¦14/3/19: 50%->75; 31/5/19: 75%->100 / Impacted TSs and TRs: New; 23.784
- 2094: 10/9/18: 0%->5¦7/12/18: 5%->35¦14/3/19: 35%->60¦14/3/19: FCD:03/19->06/19¦21/3/19: WID:SP-180382->SP-190068; 31/5/19: 60%->100 / Impacted TSs and TRs: 23.280; 23.379; 23.281; 23.282; 23.283
- 2095: 10/9/18: 0%->5¦7/12/18: 5%->35¦14/3/19: 35%->60¦14/3/19: FCD:03/19->06/19¦21/3/19: WID:SP-180382->SP-190068; 31/5/19: 60%->100; 1/7/20: 0%->100 / Impacted TSs and TRs: 23.280; 23.379; 23.281; 23.282; 23.283
- 2096: ; 26/3/20: 0%->100 / Impacted TSs and TRs: 24.379; 24.380; 24.481; 24.482; 24.483; 24.484
- 2097: 10/9/18: 0%->10¦7/12/18: 10%->40
- 2098: 10/9/18: 0%->10¦7/12/18: 10%->40¦14/3/19: 40%->75; 31/5/19: 75%->90; 13/9/19: 90%->100 / Impacted TSs and TRs: 23.280; 23.282
- 2099: 31/5/19: 0%->15; 13/9/19: 15%->25; 17/9/19: WID:CP-190199->CP-192081; 6/12/19: 25%->55; 9/12/19: FCD:12/12/2019->03/20; 9/12/19: WID:CP-192081->CP-193146; 26/3/20: 55%->70; 26/6/20: 70%->100 / Impacted TSs and TRs: 24.282; 24.582; 24.483; 24.484; 24.zzz
- 2100: 7/12/18: 0%->80¦7/3/19: 80%->90¦7/3/19: FCD:03/19->06/19; 31/5/19: 90%->100 / Impacted TSs and TRs: 26.348
- 2101: 7/12/18: 0%->80¦7/3/19: 80%->90¦7/3/19: FCD:03/19->06/19; 31/5/19: 90%->100 / Impacted TSs and TRs: 26.348
- 2102: ; 6/12/19: 0%->90; 26/3/20: 90%->100 / Impacted TSs and TRs: 29.116
- 2103: 7/12/18: 0%->20¦14/3/19: 20%->40; 31/5/19: 40%->60; 13/9/19: 60%->80; 6/12/19: 80%->90; 26/3/20: 90%->100 / Impacted TSs and TRs: 24.229; 24.281; 24.282; 24.379; 24.380; 24.481; 24.482; 24.483; 24.484; 24.581; 24.582; 24.980
- 2104: 9/12/22: Acronym:MCProtoc16_enh2MCPTT_eMCData2-ConTest->MCProtoc16_enh2MCPTT_eMCData2-UEConTest; FCD:08/09/2024->30/08/2024; Compl:0%->5%; Stat Rep: ->RP-222804; Rapporteur: NIST->Jason Kahn, NIST; Rap eMail: ->jason.kahn@nist.gov; 10/1/23: acronym re...; 14/3/24: FCD:06/09/2024->09/09/2024; Compl:42%->67%; Stat Rep: RP-232777->RP-240105; / Impacted TSs and TRs: 36.579-9; 36.579-8
- 2105: Impacted TSs and TRs: New
- 2106: 12/7/17: WID:SP-170596->SP-170598¦11/9/17: 0%->10¦15/12/17: 10%->20¦15/12/17: Changed Rel-15->Rel-16¦16/3/18: 20%->60¦23/3/18: WID:SP-170598->SP-180237¦23/3/18: FCD:03/18->06/18¦14/6/18: 60%->100 / Impacted TSs and TRs: new 23.792
- 2107: 6/8/18: 23.479 added;¦10/9/18: 0%->15¦7/12/18: 15%->65¦14/3/19: 65%->90; 31/5/19: 90%->100 / Impacted TSs and TRs: New; 23.479

| ID | WBS | Task | Type | Duration | Start | Finish | Complete | Constraint | Resources | Work | Actual work | Acronym | PCG approved | WI rapporteur name | WI rapporteur e-mail | Release | TSG approved | Status Report |
| --- | --- | --- | --- | --- | --- | --- | --- | --- | --- | --- | --- | --- | --- | --- | --- | --- | --- | --- |
| 2108 | 922 | **Enhancement of 3GPP Northbound APIs** |  | 201d | 2019-06-06 A | 2020-03-12 A | 100% |  | C3 | 4240h | 4240h | eNAPIs | 43 | Yali Yan, Huawei | yanyali@huawei.com | Rel-16 | 84 |  |
| 2109 | 922.1 | CT3 aspects of eNAPIs |  | 201d | 2019-06-06 A | 2020-03-12 A | 100% | finish no earlier than 2020-03-12 | C3 | 1608h | 1608h | eNAPIs | 43 | Yali Yan, Huawei | yanyali@huawei.com | Rel-16 | 85 |  |
| 2110 | 922.2 | CT4 aspects of eNAPIs |  | 128d | 2019-09-17 A | 2020-03-12 A | 100% | start no earlier than 2019-09-17 | C4 | 1024h | 1024h | eNAPIs | 43 | Yali Yan, Huawei | yanyali@huawei.com | Rel-16 | 85 |  |
| 2111 | 923 | Enhanced Mission Critical System Migration and Interconnection |  | 266d? | 2018-06-06 A | 2019-06-12 A | 100% | finish no earlier than 2019-06-12 | S6 | 2128h | 2128h | eMCSMI | 41 | Chater-Lea, David; Motorola Solutions | david.chater-lea@motorolasolutions.com | Rel-16 | 80 |  |
| 2112 | 924 | **Enhanced Mission Critical Communication Interworking with Land Mobile Radio Systems** |  | 268d? | 2018-06-06 A | 2019-06-14 A | 100% |  |  | 2144h | 2144h | eMCCI | 41 | Monnes, Peter, Harris Corporation | pmonnes@harris.com | Rel-16 | 80 |  |
| 2113 | 924.1 | Enhanced Mission Critical Communication Interworking with Land Mobile Radio Systems |  | 268d? | 2018-06-06 A | 2019-06-14 A | 100% | finish no earlier than 2019-06-14 | S6 | 2144h | 2144h | eMCCI | 41 | Monnes, Peter, Harris Corporation | pmonnes at harris dot com | Rel-16 | 80 |  |
| 2114 | 925 | Stage 3 for MC Communication Interworking with Land Mobile Radio Systems |  | 332d? | 2018-06-06 A | 2019-09-12 A | 100% | finish no earlier than 2019-09-12 | C1 | 2656h | 2656h | MCCI_CT | 41 | Monnes, Peter, Harris Corporation | pmonnes@harris.com | Rel-16 | 80 |  |
| 2115 | 926 | Mission Critical Services Security Enhancements |  | 527d? | 2018-06-06 A | 2020-06-11 A | 100% | finish no earlier than 2020-06-11 | S3 | 4216h | 4216h | MCXSec | 41 | Woodward, Tim, Motorola Solutions, Inc |  | Rel-16 | 80 |  |
| 2116 | 927 | **Enhancements of Public Warning System** |  | 909d? | 2016-09-19 A | 2020-03-12 A | 100% |  |  | 14752h | 14752h | ePWS | 41 | Hyounhee Koo, SyncTechno Inc. | koo at synctechno dot com | Rel-16 | 80 |  |
| 2117 | 927.1 | Study on enhancements of Public Warning System |  | 259d? | 2016-09-19 A | 2017-09-14 A | 100% | finish no earlier than 2017-09-14 | S1 | 2072h | 2072h | FS_ePWS | 37 | SyncTechno Inc., Hyounhee Koo | koo at synctechno dot com | Rel-16 | 73 |  |
| 2118 | 927.2 | Stage 1 of ePWS |  | 261d? | 2017-12-15 A | 2018-12-14 A | 100% | finish no earlier than 2018-12-14 | S1 | 2088h | 2088h | ePWS | 41 | Hyounhee Koo, SyncTechno Inc. | koo at synctechno dot com | Rel-16 | 80 |  |
| 2119 | 927.3 | **CT aspects of enhancements of Public Warning System** |  | 396d? | 2018-09-06 A | 2020-03-12 A | 100% |  | ct | 10592h | 10592h | ePWS | 41 | Hyounhee Koo, SyncTechno Inc. | koo at synctechno dot com | Rel-16 | 81 |  |
| 2120 | 927.3.1 | Study on stages 2 and 3 of enhancements of ePWS |  | 200d? | 2018-09-10 A | 2019-06-14 A | 100% | finish no earlier than 2019-06-14 | C1 | 1600h | 1600h | ePWS | 41 | Hyounhee Koo, SyncTechno Inc. | koo at synctechno dot com | Rel-16 | 81 |  |
| 2121 | 927.3.2 | CT1 aspects of ePWS |  | 396d? | 2018-09-06 A | 2020-03-12 A | 100% | finish no earlier than 2020-03-12 | C1 | 3168h | 3168h | ePWS | 41 | Hyounhee Koo, SyncTechno Inc. | koo at synctechno dot com | Rel-16 | 81 |  |
| 2122 | 927.3.3 | deleted- CT4 aspects of ePWS (Possible impacts) |  | 332d? | 2018-09-06 A | 2019-12-13 A | 100% | finish no earlier than 2019-12-13 | C4 | 2656h | 2656h | ePWS | 41 | Hyounhee Koo, SyncTechno Inc. | koo at synctechno dot com | Rel-16 | 81 |  |
| 2123 | 928 | **Mobile Communication System for Railways 2** |  | 724d? | 2017-06-05 A | 2020-03-12 A | 100% |  |  | 14864h | 14864h | MONASTERY2 | 42 | Merkel, Juergen, Nokia | juergen.merkel@nokia.com | Rel-16 | 76 |  |
| 2124 | 928.1 | Study on MONASTERY2 |  | 530d? | 2017-06-05 A | 2019-06-14 A | 100% | finish no earlier than 2019-06-14 | S1 | 4240h | 4240h | FS_FRMCS2 | 39 | Merkel, Juergen, Nokia | juergen.merkel@nokia.com | Rel-16 | 76 |  |
| 2125 | 928.2 | Study on application architecture for the Future Railway Mobile Communication System (FRMCS) Phase 2 |  | 259d? | 2018-03-15 A | 2019-03-12 A | 100% | finish no earlier than 2019-03-12 | S6 | 2072h | 2072h | FS_FRMCS2_SA6 | 40 | Oettl, Martin, Nokia | martin(dot)oettl(at)nokia(dot)com | Rel-16 | 79 |  |
| 2126 | 928.3 | Stage 1 of MONASTERY2 |  | 400d? | 2017-06-05 A | 2018-12-14 A | 100% | finish no earlier than 2018-12-14 | S1 | 3200h | 3200h | MONASTERY2 | 39 | Merkel, Juergen, Nokia | juergen.merkel@nokia.com | Rel-16 | 76 |  |
| 2127 | 928.4 | Application Architecture for MONASTERY2 | manual | 66d | 2019-03-14 A | 2019-06-13 A | 100% |  | S6 | 528h | 528h | MONASTERY2 | 42 | Oettl, Martin, Nokia | martin(dot)oettl(at)nokia(dot)com | Rel-16 | 83 |  |
| 2128 | 928.5 | **CT aspects of MONASTERY2** |  | 201d | 2019-06-06 A | 2020-03-12 A | 100% |  | ct | 4824h | 4824h | MONASTERY2 | 43 | Gkatzikis, Lazaros (Nokia) | lazaros(dot)gkatzikis(at)nokia(dot)com | Rel-16 | 84 |  |
| 2129 | 928.5.1 | CT1 aspects of MONASTERY2 |  | 201d | 2019-06-06 A | 2020-03-12 A | 100% | finish no earlier than 2020-03-12 | C1 | 1608h | 1608h | MONASTERY2 | 43 | Gkatzikis, Lazaros (Nokia) | lazaros(dot)gkatzikis(at)nokia(dot)com | Rel-16 | 84 |  |
| 2130 | 928.5.2 | deleted: CT3 aspects of MONASTERY2 |  | 201d | 2019-06-06 A | 2020-03-12 A | 100% | finish no earlier than 2020-03-12 | C3 | 1608h | 1608h | MONASTERY2 | 43 | Gkatzikis, Lazaros (Nokia) | lazaros(dot)gkatzikis(at)nokia(dot)com | Rel-16 | 84 |  |
| 2131 | 929 | **NR support for high speed train scenario** |  | 789d | 2019-06-17 A | 2022-06-22 A | 100% |  | R4 | 12608h | 12608h | NR_HST | 43 | CMCC |  | Rel-16 | 84 |  |
| 2132 | 929.1 | Core part: NR support for high speed train scenario |  | 195d | 2019-06-17 A | 2020-03-13 A | 100% | finish no earlier than 2020-03-15 | R4 | 1560h | 1560h | NR_HST-Core | 43 | CMCC |  | Rel-16 | 84 |  |
| 2133 | 929.2 | Perf. part: NR support for high speed train scenario |  | 195d | 2019-06-17 A | 2020-03-13 A | 100% | finish no earlier than 2020-03-15 | R4 | 1560h | 1560h | NR_HST-Perf | 43 | CMCC |  | Rel-16 | 84 |  |
| 2134 | 929.3 | UE Conformance Test Aspects - NR support for high speed train scenario |  | 398d | 2020-12-14 A | 2022-06-22 A | 100% | finish no earlier than 2022-06-22 | R5 | 3184h | 3184h | NR_HST-UEConTest | 46 | Dan SONG, CMCC | songdan@chinamobile.com | Rel-16 | 90 | RP-221361 |

Notes:
- 2108: ; 13/9/19: 0%->50; 17/9/19: WID:CP-191233->CP-192184; 9/12/19: WID:CP-192184->CP-193175 / Impacted TSs and TRs: 29.122; 29.222; 29.522; 29.116
- 2109: ; 13/9/19: 0%->50; 17/9/19: WID:CP-191233->CP-192184; 6/12/19: 50%->85; 6/12/19: WID:CP-192184->CP-193175; 26/3/20: 85%->100 / Impacted TSs and TRs: 29.122; 29.222; 29.522; 29.116
- 2110: ; 13/9/19: 0%->50; 17/9/19: WID:CP-191233->CP-192184; 9/12/19: 0%->80; 26/3/20: 80%->100 / Impacted TSs and TRs: 29.122; 29.222; 29.522; 29.116
- 2111: 10/9/18: 0%->5¦7/12/18: 5%->10¦7/12/18: FCD:03/19->06/19¦14/3/19: 10%->50; 31/5/19: 50%->100. / Impacted TSs and TRs: 23.280; 23.379; 23.281; 23.282; 23.283
- 2113: 10/9/18: 0%->5¦2/10/18: WID:SP-180381->SP-180680¦7/12/18: 5%->15¦14/3/19: 15%->40; 31/5/19: 40%->70; 13/9/19: 70%->100 / Impacted TSs and TRs: 23.283
- 2114: 10/9/18: 5%->15¦7/12/18: 15%->45¦10/12/18: FCD:12/18->06/19¦10/12/18: WID:CP-181187->CP-183247. 06/03/19: both name and acronym changed (was MCCI3)¦14/3/19: 45%->60¦18/3/19: WID:CP-183248->CP-190203¦18/3/19: FCD:019->09/19; 31/5/19: 60%->70; 13/9/19: 7 / Impacted TSs and TRs: 24.379; 24.380; 24.282; 24.481; 24.483; 24.484; 24.482
- 2115: 10/9/18: 0%->40¦7/12/18: 40%->50¦20/3/19: FCD:019->09/19¦20/3/19: 50%->0; 31/5/19: 0%->45; 13/9/19: FCD:12/09/2019->12/20; 6/12/19: 45%->55; 6/12/19: FCD:12/12/2019->03/20; 25/3/20: 55%->75; 26/6/20: 75%->80; 12/9/20: FCD:12/03/2020->06/20; 9/4/21: 80% / Impacted TSs and TRs: 33.180
- 2116: 16/3/18: 0%->100
- 2117: 22.xxx¦1/12/16: 0%->5¦2/3/17: 5%->45¦7/6/17: 45%->75¦30/6/17: 22.869 added;¦25/8/17: 75%->95¦15/12/17: 95%->100 / Impacted TSs and TRs: 22.869
- 2118: 16/3/18: 0%->100
- 2119: 3/6/19: WID:CP-182228->CP-191155
- 2120: 7/12/18: 0%->10¦21/3/19: 10%->30; 31/5/19: 30%->85; 3/6/19: WID:CP-182228->CP-191155; 13/9/19: 85%->100 / Impacted TSs and TRs: New
- 2121: 14/3/19: 0%->30; 3/6/19: FCD:14/06/2019->03/20; 3/6/19: WID:CP-182228->CP-191155; 20/9/19: 0%->100; 6/12/19: 100%->65; 26/3/20: 65%->95; 26/6/20: 95%->100 / Impacted TSs and TRs: 23.041
- 2122: 3/6/19: WID:CP-182228->CP-191155; 16/9/19: 0%->100 / Impacted TSs and TRs: 29.168
- 2123: 15/12/17: 10%->35 / Impacted TSs and TRs: New 22.289; 22.280; 22.281; 22.282; 22.179
- 2124: 15/12/17: 35%->50¦16/3/18: 50%->80¦7/6/18: 80%->85¦10/9/18: FCD:06/18->06/19¦4/12/18: 85%->100 / Impacted TSs and TRs: New 22.889
- 2125: 19/4/18: 0%->5¦14/6/18: 5%->15¦6/8/18: 23.796 added;¦10/9/18: 15%->20¦7/12/18: 20%->65¦7/12/18: FCD:12/18->03/19¦14/3/19: 65%->100 / Impacted TSs and TRs: 23.cde; 23.796
- 2126: 16/3/18: 35%->55¦7/6/18: 55%->70¦7/6/18: FCD:06/18->12/18¦10/9/18: 70%->75¦4/12/18: 75%->100 / Impacted TSs and TRs: New 22.289; 22.280; 22.281; 22.282; 22.179
- 2127: 31/5/19: 0%->100 / Impacted TSs and TRs: 23.280; 23.379; 23.281; 23.282
- 2128: 9/12/19: WID:CP-191152->CP-193143
- 2129: 13/9/19: 0%->10; 6/12/19: 10%->50; 26/3/20: 50%->65; 26/6/20: 65%->100 / Impacted TSs and TRs: 24.379 ; 24.281 ; 24.282 ; 24.481 ; 24.483 ; 24.484 ; 24.581; 24.582
- 2130: 2/7/20: deleted, put at 100% (was at 0) / Impacted TSs and TRs: 29.165
- 2131: 8/10/19: WID:RP-191512->RP-191788
- 2132: 28/7/20: 0%->100
- 2133: 6/1/21: WID:RP-191788->RP-202320; 6/1/21: 0%->100
- 2134: tested: REL-16 WI NR_HST-Core ; 7/4/21: WID:RP-202328->RP-210372; 8/4/21: 0%->39; 2/7/21: 39%->41; 13/9/21: Compl:41%->44%; ; 20/6/22: Rapporteur: CMCC->Dan SONG, CMCC; Rap eMail: ->songdan@chinamobile.com12/7/22: WID:RP-202328->RP-221362

| ID | WBS | Task | Type | Duration | Start | Finish | Complete | Remaining | Total slack | Constraint | Resources | Work | Actual work | Acronym | PCG approved | WI rapporteur name | WI rapporteur e-mail | Release | TSG approved |
| --- | --- | --- | --- | --- | --- | --- | --- | --- | --- | --- | --- | --- | --- | --- | --- | --- | --- | --- | --- |
| 2135 | 930 | **Maritime Communication Services over 3GPP System** |  | 584d? | 2016-09-19 A | 2018-12-13 A | 100% |  |  |  | S1 | 5950h | 5950h | MARCOM | 41 | Hyounhee Koo, SyncTechno Inc | koo at synctechno dot com | Rel-16 | 80 |
| 2136 | 930.1 | Study on Maritime Communication Services over 3GPP system |  | 455d? | 2016-09-19 A | 2018-06-15 A | 100% |  |  | finish no earlier than 2018-06-15 | S1 | 3640h | 3640h | FS_MARCOM | 37 | SyncTechno Inc., Hyounhee Koo | koo at synctechno dot com | Rel-16 | 73 |
| 2137 | 930.2 | Stage 1 of MARCOM |  | 137d? | 2018-06-06 A | 2018-12-13 A | 100% |  |  | finish no earlier than 2018-12-13 | S1 | 1096h | 1096h | MARCOM | 41 | Hyounhee Koo, SyncTechno Inc | koo at synctechno dot com | Rel-16 | 80 |
| 2138 | 931 | Streaming and TV |  | 655d? | 2016-12-01 A | 2019-06-05 A | 100% |  |  |  |  |  |  |  |  |  |  | Rel-16 |  |
| 2139 | 932 | **Enhancement of LTE for Efficient delivery of Streaming Service** |  | 467d? | 2016-12-01 A | 2018-09-14 A | 100% |  |  |  | S1 | 7176h | 7176h | eLSTR | 41 | Xia, Xu, China Telecom | xiaxu.bri@chinatelecom.cn | Rel-16 | 80 |
| 2140 | 932.1 | Study on eLSTR |  | 336d? | 2016-12-01 A | 2018-03-15 A | 100% |  |  | finish no earlier than 2018-03-15 | S1 | 2688h | 2688h | FS_eLESTR | 38 | China Telecommunications, XIA Xu | xiaxu@ctbri.com.cn | Rel-16 | 74 |
| 2141 | 932.2 | Stage 1 of eLSTR |  | 94d? | 2018-05-08 A | 2018-09-14 A | 100% |  |  | finish no earlier than 2018-09-14 | S1 | 752h | 752h | eLSTR | 41 | Xia, Xu, China Telecom | xiaxu.bri@chinatelecom.cn | Rel-16 | 80 |
| 2142 | 933 | Enhancements to Framework for Live Uplink Streaming |  | 543d? | 2018-06-06 A | 2020-07-03 | 95% | 27.15d? | 0d | finish no earlier than 2020-07-03 | S4 | 4344h | 4344h | E_FLUS | 41 | Lo, Charles, Qualcomm Incorporated | clo@qti.qualcomm.com | Rel-16 | 80 |
| 2143 | 934 | Coverage and Handoff Enhancements for Multimedia |  | 197d? | 2018-09-06 A | 2019-06-07 A | 100% |  |  | finish no earlier than 2019-06-07 | S4 | 1576h | 1576h | CHEM | 41 | Nikolai Leung | nleung@qti.qualcomm.com | Rel-16 | 81 |
| 2144 | 935 | Study on QoE metrics for VR |  | 531d? | 2017-09-08 A | 2019-09-20 A | 100% |  |  | finish no earlier than 2019-09-20 | S4 | 4248h | 4248h | FS_QoE_VR | 39 | Ericsson (Gunnar Heikkilä | gunnar.heikkila@ericsson.com | Rel-16 | 77 |
| 2145 | 936 | Study on 5G enhanced Mobile Broadband Media Distribution |  | 335d? | 2017-06-05 A | 2018-09-14 A | 100% |  |  | finish no earlier than 2018-09-14 | S4 | 2680h | 2680h | FS_5GMedia_Distribution | 39 | Bouazizi, Imed, Samsung Electronics Co., Ltd., | i (dot) Bouazizi (at) Samsung (dot) com | Rel-16 | 76 |
| 2146 | 937 | Media streaming architecture | manual | 135d | 2018-12-06 A | 2019-06-12 A | 100% |  |  |  | S4 | 1080h | 1080h | 5GMSA | 42 | Frédéric GABIN | Frederic.gabin@ericsson.com | Rel-16 | 82 |
| 2147 | 938 | VR QoE metrics |  | 201d | 2019-06-06 A | 2020-03-12 A | 100% |  |  | finish no earlier than 2020-03-12 | S4 | 1608h | 1608h | VRQoE | 43 | Gunnar HEIKKILÄ | gunnar.heikkila@ericsson.com | Rel-16 | 84 |
| 2148 | 939 | **Media Handling Extensions for 5G Conversational Services** |  | 659d? | 2017-06-05 A | 2019-12-12 A | 100% |  |  |  | S4 | 10600h | 10600h | 5G_MEDIA_MTSI_ext | 41 | Oyman, Ozgur, Company: Intel | ozgur.oyman@intel.com | Rel-16 | 81 |
| 2149 | 939.1 | Study on Media Handling Aspects of Conversational Services in 5G Systems |  | 335d? | 2017-06-05 A | 2018-09-14 A | 100% |  |  | finish no earlier than 2018-09-15 | S4 | 2680h | 2680h | FS_5G_MEDIA_MTSI | 39 | Oyman, Ozgur, Company: Intel | ozgur.oyman@intel.com | Rel-16 | 76 |
| 2150 | 939.2 | Media Handling Extensions for 5G Conversational Services |  | 331d? | 2018-09-06 A | 2019-12-12 A | 100% |  |  | finish no earlier than 2019-12-12 | S4 | 2648h | 2648h | 5G_MEDIA_MTSI_ext | 41 | Oyman, Ozgur, Company: Intel | ozgur.oyman@intel.com | Rel-16 | 81 |
| 2151 | 940 | Study on EVS Float Conformance Non Bit-Exact |  | 266d? | 2017-09-08 A | 2018-09-14 A | 100% |  |  | finish no earlier than 2018-09-14 | S4 | 2128h | 2128h | FS_EVS_FCNBE | 39 | Fabrice Plante, Intel | fabrice.m.plante@intel.com | Rel-16 | 77 |
| 2152 | 941 | EVS Floating-point Conformance for Non Bit-Exact |  | 397d? | 2018-06-06 A | 2019-12-12 A | 100% |  |  | finish no earlier than 2019-12-12 | S4 | 3176h | 3176h | EVS_FCNBE | 42 | Fabrice, Plante, Intel | fabrice.m.plante@intel.om | Rel-16 | 82 |
| 2153 | 942 | Addition of HLG HDR to TV Video Profiles |  | 73d? | 2018-06-06 A | 2018-09-14 A | 100% |  |  | finish no earlier than 2018-09-14 | S4 | 584h | 584h | HLG_HDR | 41 | Paul Szucs, Sony Europe Limited | paul.szucs@sony.com | Rel-16 | 80 |
| 2154 | 943 | User Identities, Authentication, multi-device | milestone | 0d? | 2017-12-15 A | 2017-12-15 A | 100% |  |  | finish no earlier than 2017-12-15 |  |  |  |  |  |  |  | Rel-16 |  |
| 2155 | 944 | **User Identities and Authentication** |  | 196d? | 2017-12-15 A | 2018-09-14 A | 100% |  |  |  | S1 | 3192h | 3192h | UIA | 41 | Bischinger, Kurt; Deutsche Telekom | kurt.bischinger@t-mobile.at | Rel-16 | 80 |
| 2156 | 944.1 | Study on a Layer for User Centric Identifiers and Authentication |  | 130d? | 2017-12-15 A | 2018-06-14 A | 100% |  |  | finish no earlier than 2018-06-14 | S1 | 1040h | 1040h | FS_LUCIA | 40 | Bischinger, Kurt; Deutsche Telekom | kurt.bischinger@t-mobile.at | Rel-16 | 78 |
| 2157 | 944.2 | Stage 1 of User Identities and Authentication |  | 73d? | 2018-06-06 A | 2018-09-14 A | 100% |  |  | finish no earlier than 2018-09-14 | S1 | 584h | 584h | UIA | 41 | Bischinger, Kurt; Deutsche Telekom | kurt.bischinger@t-mobile.at | Rel-16 | 80 |
| 2158 | 945 | **Multi-device and multi-identity** |  | 529d? | 2018-06-06 A | 2020-06-15 A | 100% |  |  |  |  | 11696h | 11696h | MuD | 41 | Peter Bleckert, Ericsson | Peter.Bleckert@ericsson.com | Rel-16 | 80 |
| 2159 | 945.1 | Stage 1 of Multi-device and multi-identity |  | 73d? | 2018-06-06 A | 2018-09-14 A | 100% |  |  | finish no earlier than 2018-09-14 | S1 | 584h | 584h | MuD | 41 | Peter Bleckert, Ericsson | Peter.Bleckert@ericsson.com | Rel-16 | 80 |

Notes:
- 2135: Impacted TSs and TRs: 22.179; 22.280; 22.281; 22.282; 22.261; 22.346; 22.468
- 2136: 22.xxx¦1/12/16: 0%->10¦2/3/17: 10%->15¦2/3/17: WID:SP-160556->SP-170166¦10/3/17: FCD:06/17->06/20¦21/3/17: 22.819 added;¦8/6/17: WID:SP-170166->SP-170453¦25/8/17: 15%->35¦15/12/17: 35%->55¦16/3/18: 55%->75¦7/6/18: 75%->95¦10/9/18: 95%->100 / Impacted TSs and TRs: 22.819
- 2137: 10/9/18: 0%->70¦4/12/18: 70%->95¦14/3/19: 95%->100 / Impacted TSs and TRs: 22.119; 22.179; 22.280; 22.281; 22.282; 22.261; 22.346; 22.468
- 2138: -
- 2139: Impacted TSs and TRs: 22.278; 22.115
- 2140: 2/3/17: 0%->20¦7/6/17: 20%->50¦11/9/17: 50%->70¦15/12/17: 70%->75¦15/12/17: FCD:09/17->03/18¦16/3/18: 75%->100 / Impacted TSs and TRs: 22.833
- 2141: 15/6/18: FCD:06/18->09/18¦10/9/18: 90%->100 / Impacted TSs and TRs: 22.278; 22.115
- 2142: 10/9/18: 0%->20¦7/12/18: 20%->40¦7/3/19: 40%->45¦7/3/19: FCD:03/19->09/19; 31/5/19: 45%->55; 13/9/19: FCD:20/09/2019->12/20; 13/9/19: 55%->75; 6/12/19: 75%->85; 25/3/20: 85%->90; 25/3/20: FCD:12/12/2019->06/20; 10/6/20: 90%->100; 26/6/20: FCD:12/06/202 / Impacted TSs and TRs: 26.238; 26.939
- 2143: 7/12/18: 0%->70¦7/3/19: 70%->80¦7/3/19: FCD:03/19->06/19; 31/5/19: 80%->90; 13/9/19: 90%->100 / Impacted TSs and TRs: 26.114
- 2144: 15/12/17: 26.929 added;¦15/12/17: 26.119 added;¦15/12/17: FCD:06/18->09/18¦15/12/17: 0%->10¦16/3/18: 10%->15¦7/6/18: 15%->20¦7/6/18: FCD:09/18->12/18. 14/06/18: Moved from Rel-15¦10/9/18: 20%->25¦12/3/19: 25%->55¦12/3/19: FCD:12/18->09/19; 31/5/19: 55% / Impacted TSs and TRs: New; 26.929; 26.119
- 2145: 11/9/17: 0%->10¦15/12/17: FCD:03/18->06/20¦15/12/17: 10%->25¦16/3/18: 25%->60¦7/6/18: 60%->70¦7/6/18: FCD:06/18->09/18. 14/06/18: Moved from Rel-15¦10/9/18: 70%->75; 26/6/20: 75%->100; 25/9/20: 26.998 added; / Impacted TSs and TRs: 26.8xx; 26.998
- 2146: ; 31/5/19: 0%->100 / Impacted TSs and TRs: 26.501; 26.233
- 2147: 22.280¦22.281¦22.282¦22.179¦22.289 ; 13/9/19: 0%->25; 6/12/19: 25%->50; 6/12/19: FCD:12/12/2019->03/20; 25/3/20: 50%->100 / Impacted TSs and TRs: 22.280; 22.281; 22.282; 22.179; 22.289
- 2148: Impacted TSs and TRs: 26.114
- 2149: 11/9/17: 0%->5¦15/12/17: 5%->35¦16/3/18: 35%->55¦16/3/18: FCD:03/18->09/18¦7/6/18: 55%->80. 14/06/18: Moved from Rel-15¦10/9/18: 80%->100 / Impacted TSs and TRs: 26.919
- 2150: 7/12/18: 0%->35¦7/3/19: 35%->50; 31/5/19: 50%->75; 13/9/19: 75%->80; 13/9/19: FCD:13/09/2019->12/20; 19/9/19: WID:SP-180663->SP-190640; 6/12/19: 80%->90; 25/3/20: 90%->100 / Impacted TSs and TRs: 26.114; 26.131; 26.132; 26.223; 26.919
- 2151: 15/12/17: 26.843 added;¦15/12/17: 0%->50¦16/3/18: 50%->60¦16/3/18: FCD:03/18->06/18¦7/6/18: 60%->70¦7/6/18: FCD:06/18->09/18. 14/06/18: Moved from Rel-15¦10/9/18: 70%->100 / Impacted TSs and TRs: New; 26.843
- 2152: ¦7/3/19: 0%->25¦7/3/19: 0%->25¦7/3/19: 0%->25. CANNOT CHANGE STARTING DATE… Real one: Thu 06/12/18; 31/5/19: 25%->50; 13/9/19: 50%->80; 13/9/19: FCD:12/09/2019->12/20; 6/12/19: 80%->100 / Impacted TSs and TRs: 26.444
- 2153: 10/9/18: 0%->100 / Impacted TSs and TRs: 26.116; 26.346; 26.234
- 2154: -
- 2155: Impacted TSs and TRs: 22.101; 22.115
- 2156: 16/3/18: 0%->60¦7/6/18: 60%->90¦10/9/18: 90%->100 / Impacted TSs and TRs: 22.904
- 2157: 10/9/18: 0%->100 / Impacted TSs and TRs: 22.101; 22.115
- 2159: 10/9/18: 85%->90¦4/12/18: 90%->100 / Impacted TSs and TRs: 22.173

| ID | WBS | Task | Type | Duration | Start | Finish | Complete | Remaining | Total slack | Constraint | Resources | Work | Actual work | Acronym | PCG approved | WI rapporteur name | WI rapporteur e-mail | Release | TSG approved | Status Report |
| --- | --- | --- | --- | --- | --- | --- | --- | --- | --- | --- | --- | --- | --- | --- | --- | --- | --- | --- | --- | --- |
| 2160 | 945.2 | **CT aspects of Multi-device and multi-identity** |  | 463d? | 2018-09-06 A | 2020-06-15 A | 100% |  |  |  | ct | 11112h | 11112h | MuD | 41 | Axell, Jörgen, Ericsson | Jorgen.Axell@ericsson.com | Rel-16 | 81 |  |
| 2161 | 945.2.1 | CT1 aspects of Multi-device and multi-identity |  | 463d? | 2018-09-06 A | 2020-06-15 A | 100% |  |  | finish no earlier than 2020-06-15 | C1 | 3704h | 3704h | MuD | 41 | Axell, Jörgen, Ericsson | Jorgen.Axell@ericsson.com | Rel-16 | 81 |  |
| 2162 | 945.2.2 | CT3 aspects of Multi-device and multi-identity |  | 463d? | 2018-09-06 A | 2020-06-15 A | 100% |  |  | finish no earlier than 2020-06-15 | C3 | 3704h | 3704h | MuD | 41 | Axell, Jörgen, Ericsson | Jorgen.Axell@ericsson.com | Rel-16 | 81 |  |
| 2163 | 946 | Slicing | milestone | 0d? | 2017-09-08 A | 2017-09-08 A | 100% |  |  | finish no earlier than 2017-09-08 |  |  |  |  |  |  |  | Rel-16 |  |  |
| 2164 | 947 | **Enhancement of Network Slicing** |  | 1174d? | 2018-03-15 A | 2022-09-12 | 94% | 70.27d? | 909d |  |  | 18856h | 17344h | eNS | 42 | ZTE, Tricci So | tso at ztetx dot com | Rel-16 | 83 |  |
| 2165 | 947.1 | Study on Enhancement of Network Slicing |  | 197d? | 2018-03-15 A | 2018-12-14 A | 100% |  |  | start no earlier than 2018-03-15 | S2 | 1576h | 1576h | FS_eNS | 40 | ZTE, Tricci So | tso at ztetx dot com | Rel-16 | 79 |  |
| 2166 | 947.2 | Stage 2 of eNS |  | 136d | 2018-12-13 A | 2019-06-20 A | 100% |  |  | start no earlier than 2018-12-13 | S2 | 1088h | 1088h | eNS | 42 | ZTE, Tricci So | tso at ztetx dot com | Rel-16 | 82 |  |
| 2167 | 947.3 | **CT aspects of eNS** |  | 196d | 2019-03-07 A | 2019-12-05 A | 100% |  |  |  | ct | 6272h | 6272h | eNS | 42 | Fei Lu, ZTE | lu.fei1@zte.com.cn | Rel-16 | 83 |  |
| 2168 | 947.3.1 | CT1 aspects of eNS |  | 196d | 2019-03-07 A | 2019-12-05 A | 100% |  |  |  | C1 | 1568h | 1568h | eNS | 42 | Fei Lu, ZTE | lu.fei1@zte.com.cn | Rel-16 | 83 |  |
| 2169 | 947.3.2 | CT3 aspects of eNS |  | 196d | 2019-03-07 A | 2019-12-05 A | 100% |  |  |  | C3 | 1568h | 1568h | eNS | 42 | Fei Lu, ZTE | lu.fei1@zte.com.cn | Rel-16 | 83 |  |
| 2170 | 947.3.3 | CT4 aspects of eNS |  | 196d | 2019-03-07 A | 2019-12-05 A | 100% |  |  |  | C4 | 1568h | 1568h | eNS | 42 | Fei Lu, ZTE | lu.fei1@zte.com.cn | Rel-16 | 83 |  |
| 2171 | 947.4 | Study on Security aspects of Enhancement of Network Slicing |  | 396d? | 2018-09-06 A | 2020-03-12 A | 100% |  |  | finish no earlier than 2020-03-12 | S3 | 3168h | 3168h | FS_eNS_SEC | 41 |  | Suresh.p.nair@nokia.com | Rel-16 | 81 |  |
| 2172 | 947.5 | Security aspects of Enhanced Network Slicing |  | 452d | 2019-09-19 A | 2021-06-11 A | 100% |  |  | finish no earlier than 2021-06-12 | S3 | 3616h | 3616h | eNS | 43 | Suresh.p.nair@nokia.com |  | Rel-16 | 85 |  |
| 2173 | 947.6 | UE Conformance Test Aspects - Enhancement of Network Slicing |  | 392d | 2021-03-12 A | 2022-09-12 | 67% | 129.36d | 909d | finish no earlier than 2022-09-12 | R5 | 3136h | 1624h | eNS-UEConTest | 46 | CMCC |  | Rel-16 | 91 | R5-220262 |
| 2174 | 948 | **Business Role Models for Network Slicing** |  | 330d? | 2017-09-08 A | 2018-12-13 A | 100% |  |  |  | S1 | 5336h | 5336h | BRMNS | 41 | Covell, Betsy, Nokia | betsy.covell@nokia.com | Rel-16 | 81 |  |
| 2175 | 948.1 | Study on Business Role Models for Network Slicing |  | 266d? | 2017-09-08 A | 2018-09-14 A | 100% |  |  | start no earlier than 2017-09-08 | S1 | 2128h | 2128h | FS_BMNS | 39 | Covell, Betsy, Nokia | betsy.covell@nokia.com | Rel-16 | 77 |  |
| 2176 | 948.2 | Business Role Models for Network Slicing |  | 71d? | 2018-09-06 A | 2018-12-13 A | 100% |  |  | finish no earlier than 2018-12-13 | S1 | 568h | 568h | BRMNS | 41 | Covell, Betsy, Nokia | betsy.covell@nokia.com | Rel-16 | 81 |  |
| 2177 | 949 | Study on tenancy concept in 5G networks and network slicing management |  | 202d? | 2018-09-06 A | 2019-06-14 A | 100% |  |  | finish no earlier than 2019-06-14 | S5 | 1616h | 1616h | FS_TENANCYC | 41 | ZHU, Lei (Huawei | Lei.zhu@huawei.com | Rel-16 | 81 |  |
| 2178 | 950 | **Enhancement of performance assurance for 5G networks including network slicing** |  | 396d? | 2018-09-06 A | 2020-03-12 A | 100% |  |  |  | S5 | 6824h | 6824h | 5G_SLICE_ePA | 41 | Xiaowei Sun (China Mobile) |  | Rel-16 | 81 |  |
| 2179 | 950.1 | Overall aspects of 5G_SLICE_ePA |  | 331d? | 2018-09-06 A | 2019-12-12 A | 100% |  |  | finish no earlier than 2019-12-12 | S5 | 2648h | 2648h | 5G_SLICE_ePA | 41 | Xiaowei Sun (China Mobile) |  | Rel-16 | 81 |  |
| 2180 | 950.2 | KPI reporting |  | 126d | 2019-09-19 A | 2020-03-12 A | 100% |  |  | finish no earlier than 2020-03-12 | S5 | 1008h | 1008h | 5G_SLICE_ePA-KPI | 43 | ZHU, Weihong, ZTE Corporation | zhu.weihong@zte.com.cn | Rel-16 | 85 |  |
| 2181 | 951 | Study on Charging Aspects of Network Slicing |  | 261d | 2018-12-13 A | 2019-12-12 A | 100% |  |  | finish no earlier than 2019-12-12 | S5 | 2088h | 2088h | FS_NETSLICE_CH | 42 | Chen Shan, Huawei | chenshan@huawei.com | Rel-16 | 82 |  |
| 2182 | 952 | Other cross-TSG Release 16 Features | milestone | 0d? | 2016-06-09 A | 2016-06-09 A | 100% |  |  | finish no earlier than 2016-06-09 |  |  |  |  |  |  |  | Rel-16 |  |  |
| 2183 | 953 | **Provision of Access to Restricted Local Operator Services by Unauthenticated UEs** |  | 792d? | 2016-12-01 A | 2019-12-13 A | 100% |  |  |  |  | 18200h | 18200h | PARLOS | 38 | Covell, Betsy Nokia | betsy.covell@nokia.com | Rel-16 | 76 |  |
| 2184 | 953.1 | Study on Stage 1 of PARLOS |  | 463d? | 2016-12-01 A | 2018-09-10 A | 100% |  |  | finish no earlier than 2018-09-10 | S1 | 3704h | 3704h | FS_PARLOS | 38 | Covell, Betsy | betsy.covell@nokia.com | Rel-15 | 74 |  |
| 2185 | 953.2 | Study on Stage 2 for PARLOS |  | 335d? | 2017-06-05 A | 2018-09-14 A | 100% |  |  | finish no earlier than 2018-09-14 | S2 | 2680h | 2680h | FS_PARLOS_SA2 | 39 | Nokia (Nicolas Drevon | nicolas.drevon@nokia.com | Rel-16 | 76 |  |
| 2186 | 953.3 | Study on Security Aspects of PARLOS |  | 332d? | 2018-06-06 A | 2019-09-12 A | 100% |  |  | finish no earlier than 2019-09-12 | S3 | 2656h | 2656h | FS_PARLOS_Sec | 41 | Greg Schumacher, Sprint | Gregory.schumacher@sprint.com | Rel-16 | 80 |  |
| 2187 | 953.4 | Stage 1 of PARLOS |  | 22d? | 2017-05-10 A | 2017-06-08 A | 100% |  |  | finish no earlier than 2017-06-08 | S1 | 176h | 176h | PARLOS | 39 | Covell, Betsy Nokia | betsy.covell@nokia.com | Rel-16 | 76 |  |
| 2188 | 953.5 | Stage 2 of PARLOS |  | 137d? | 2018-09-06 A | 2019-03-15 A | 100% |  |  | finish no earlier than 2019-03-15 | S2 | 1096h | 1096h | PARLOS | 41 | Nokia (Nicolas Drevon | nicolas.drevon@nokia.com) | Rel-16 | 81 |  |

Notes:
- 2160: 9/12/19: WID:CP-182227->CP-193273; 25/3/20: WID:CP-193273->CP-200148
- 2161: 7/12/18: 0%->10¦14/3/19: 10%->15; 31/5/19: 15%->35; 13/9/19: 35%->65; 6/12/19: 65%->85; 25/3/20: FCD:14/06/2019->03/20; 26/3/20: 85%->100; 2/7/20: FCD:25/03/2020->06/20 / Impacted TSs and TRs: 24.173; 24.229; 24.167
- 2162: 7/12/18: 0%->5; 13/9/19: 5%->95; 6/12/19: 95%->98; 26/3/20: 98%->100; 2/7/20: FCD:25/03/2020->06/20 / Impacted TSs and TRs: 29.165
- 2163: -
- 2165: 7/6/18: 0%->10¦15/6/18: WID:SP-180121->SP-180503¦6/8/18: 23.740 added;¦10/9/18: 10%->50¦7/12/18: 50%->85¦7/12/18: 85%->¦14/3/19: 85%->100 / Impacted TSs and TRs: new; 23.740
- 2166: 14/3/19: 0%->60; 31/5/19: 60%->100
- 2167: 2/7/20: WID:CP-190196->CP-201161
- 2168: 13/9/19: 0%->40; 6/12/19: 40%->85; 26/3/20: 85%->95; 26/6/20: 95%->97; 13/9/20: 97%->100 / Impacted TSs and TRs: 24.501
- 2169: 6/12/19: 0%->80; 26/3/20: 80%->98; 26/6/20: 98%->100 / Impacted TSs and TRs: 29.061; 29.561
- 2170: 31/5/19: 0%->30; 13/9/19: 30%->50; 6/12/19: 50%->95; 26/3/20: 95%->85 (went down); 26/6/20: 85%->100 / Impacted TSs and TRs: 29.502; 29.503; 29.505; 29.509; 29.518
- 2171: 7/12/18: 0%->15¦20/3/19: 15%->65¦20/3/19: FCD:019->06/19; 31/5/19: 65%->75; 13/9/19: FCD:12/06/2019->12/20; 13/9/19: 75%->80; 6/12/19: 80%->85; 6/12/19: FCD:12/12/2019->03/20; 26/6/20: 85%->100 / Impacted TSs and TRs: New
- 2172: ; 6/12/19: 0%->30; 6/12/19: FCD:12/12/2019->03/20; 25/3/20: FCD:12/03/2020->06/20; 26/6/20: 30%->95; 12/9/20: 95%->97; 19/3/21: FCD:12/06/2020->06/21; 11/6/21: 97%->100 / Impacted TSs and TRs: New
- 2173: tested: CT1 and SA3 REL-16 WI eNS (Enhancement of Network Slicing); compare REL-17 SI FS_NR_slice; 2/7/21: 0%->15; 13/9/21: Compl:15%->47%; ; 6/1/22: 47%->100 ;
- 2174: Impacted TSs and TRs: 22.261
- 2175: 15/12/17: 22.830 added;¦15/12/17: 0%->10¦15/3/18: WID:SP-170705->SP-180169¦16/3/18: 10%->50¦7/6/18: 50%->75¦10/9/18: 75%->95¦4/12/18: 95%->100 / Impacted TSs and TRs: New; 22.830
- 2176: 10/9/18: 0%->95¦4/12/18: 95%->100 / Impacted TSs and TRs: 22.261
- 2177: 7/12/18: 0%->20¦14/3/19: 20%->26; 31/5/19: 26%->40; 13/9/19: 40%->100 / Impacted TSs and TRs: New
- 2178: 7/12/18: 0%->30¦17/1/19: WID:SP-180843->SP-180906¦14/3/19: 30%->60¦21/3/19: FCD:06/19->12/19¦21/3/19: WID:SP-180906(->SP-190141)->SP-190247; 31/5/19: 60%->70 / Impacted TSs and TRs: 28.550; 28.532; 28.552; 28.554; 32.425; 32.426; 32.450; 32.451; 32.455; 28.622; 28.623
- 2179: 7/12/18: 0%->30¦17/1/19: WID:SP-180843->SP-180906¦14/3/19: 30%->60¦21/3/19: FCD:06/19->12/19¦21/3/19: WID:SP-180906(->SP-190141)->SP-190247; 31/5/19: 60%->70; 13/9/19: 70%->85; 13/9/19: 85%->; 26/3/20: 85%->97; 28/6/20: 97%->100 / Impacted TSs and TRs: 28.550; 28.532; 28.552; 28.554; 32.425; 32.426; 32.450; 32.451; 32.455; 28.622; 28.623
- 2180: ; 26/3/20: 0%->100 / Impacted TSs and TRs: 28.550; 28.554; 28.622; 28.532
- 2181: 14/3/19: 0%->30¦14/3/19: FCD:06/19->09/19; 31/5/19: 30%->45; 13/9/19: 45%->85; 13/9/19: FCD:12/09/2019->12/20; 6/12/19: 85%->100
- 2182: -
- 2183: 16/03/18: Moved to Rel-16 as per SA2 chair indication that St 2 work to be shifted from Rel-15 to Rel-16 / Impacted TSs and TRs: 22.115; 22.101; 22.228
- 2184: 1/12/16: 0%->75¦2/3/17: 75%->100¦10/9/18: FCD:03/17->09/18 / Impacted TSs and TRs: 22.820
- 2185: 11/9/17: 0%->20¦16/3/18: FCD:12/17->12/18.¦16/3/18: 20%->45¦23/3/18: WID:SP-170382->SP-180116¦23/3/18: FCD:12/18->06/18¦7/6/18: 45%->70¦15/6/18: WID:SP-180116->SP-180501¦15/6/18: FCD:06/18->09/18¦10/9/18: 70%->100 / Impacted TSs and TRs: 23.715
- 2186: 6/8/18: 33.815 added;¦10/9/18: 0%->5¦7/12/18: 5%->50¦20/3/19: FCD:018->09/19¦20/3/19: 50%->55; 31/5/19: 55%->60; 13/9/19: 60%->100 / Impacted TSs and TRs: New; 33.815
- 2187: 7/6/17: 0%->100 / Impacted TSs and TRs: 22.115; 22.101; 22.228
- 2188: 14/3/19: 0%->95; 31/5/19: 95%->100 / Impacted TSs and TRs: 23.401; 23.203; 23.221; 23.228; 23.167

| ID | WBS | Task | Duration | Start | Finish | Complete | Constraint | Resources | Work | Actual work | Acronym | PCG approved | WI rapporteur name | WI rapporteur e-mail | Release | TSG approved | Impacted TSs and TRs | Status Report |
| --- | --- | --- | --- | --- | --- | --- | --- | --- | --- | --- | --- | --- | --- | --- | --- | --- | --- | --- |
| 2189 | 953.6 | **CT aspects of PARLOS** | 196d? | 2019-03-14 A | 2019-12-12 A | 100% |  | ct | 7840h | 7840h | PARLOS | 42 | Liu, Jennifer; Nokia | Jennifer.Liu@nokia.com | Rel-16 | 83 |  |  |
| 2190 | 953.6.1 | CT1 aspects of PARLOS | 196d? | 2019-03-14 A | 2019-12-12 A | 100% | finish no earlier than 2019-12-12 | C1 | 1568h | 1568h | PARLOS | 42 | Liu, Jennifer; Nokia | Jennifer.Liu@nokia.com | Rel-16 | 83 | 24.301; 24.008; 23.122; 24.368; 24.167; 24.229; 27.007 |  |
| 2191 | 953.6.2 | CT3 aspects of PARLOS | 196d? | 2019-03-14 A | 2019-12-12 A | 100% | finish no earlier than 2019-12-12 | C3 | 1568h | 1568h | PARLOS | 42 | Liu, Jennifer; Nokia | Jennifer.Liu@nokia.com | Rel-16 | 83 | 29.212; 29.213; 29.214 |  |
| 2192 | 953.6.3 | CT4 aspects of PARLOS | 196d? | 2019-03-14 A | 2019-12-12 A | 100% | finish no earlier than 2019-12-12 | C4 | 1568h | 1568h | PARLOS | 42 | Liu, Jennifer; Nokia | Jennifer.Liu@nokia.com | Rel-16 | 83 | 29.228; 29.229; 29.274 |  |
| 2193 | 953.6.4 | CT6 aspects of PARLOS | 196d? | 2019-03-14 A | 2019-12-12 A | 100% | finish no earlier than 2019-12-12 | C6 | 1568h | 1568h | PARLOS | 42 | Liu, Jennifer; Nokia | Jennifer.Liu@nokia.com | Rel-16 | 83 | 31.102; 31.103 |  |
| 2194 | 953.7 | Security Aspects of PARLOS | 6d | 2019-12-06 A | 2019-12-13 A | 100% | finish no earlier than 2019-12-13 | S3 | 48h | 48h | PARLOS | 44 | Schumacher, Greg, Sprint | Gregory.schumacher@sprint.com | Rel-16 | 86 | 33.401 |  |
| 2195 | 954 | **Enhancing Topology of SMF and UPF in 5G Networks** | 655d? | 2017-09-08 A | 2020-03-12 A | 100% |  |  | 9456h | 9456h | ETSUN | 42 |  |  | Rel-16 | 82 |  |  |
| 2196 | 954.1 | Study on ETSUN | 331d? | 2017-09-08 A | 2018-12-14 A | 100% | finish no earlier than 2018-12-15 | S2 | 2648h | 2648h | FS_ETSUN | 39 | Laurent Thiebaut (Nokia) | Laurent.thiebaut@nokia.com | Rel-16 | 77 | 23.726 |  |
| 2197 | 954.2 | Stage 2 of ETSUN | 137d | 2018-12-07 A | 2019-06-17 A | 100% | start no earlier than 2018-12-07 | S2 | 1096h | 1096h | ETSUN | 42 |  |  | Rel-16 | 82 |  |  |
| 2198 | 954.3 | **CT aspects of ETSUN** | 196d | 2019-03-08 A | 2019-12-06 A | 100% |  | ct | 4704h | 4704h | ETSUN | 42 | Landais, Bruno, Nokia | bruno.landais@nokia.com | Rel-16 | 83 |  |  |
| 2199 | 954.3.1 | CT3 aspects of ETSUN | 196d | 2019-03-08 A | 2019-12-06 A | 100% | start no earlier than 2019-03-08 | C3 | 1568h | 1568h | ETSUN | 42 | Landais, Bruno, Nokia | bruno.landais@nokia.com | Rel-16 | 83 | 29.508; 29.561 |  |
| 2200 | 954.3.2 | CT4 aspects of ETSUN | 196d | 2019-03-08 A | 2019-12-06 A | 100% | start no earlier than 2019-03-08 | C4 | 1568h | 1568h | ETSUN | 42 | Landais, Bruno, Nokia | bruno.landais@nokia.com | Rel-16 | 83 | 29.244; 29.502; 29.510; 29.518; 29.281 |  |
| 2201 | 954.4 | Charging aspects of ETSUN | 126d | 2019-09-19 A | 2020-03-12 A | 100% | finish no earlier than 2020-03-12 | S5 | 1008h | 1008h | ETSUN | 43 | Dong, Jia, China Mobile | dongjia@chinamobile.com | Rel-16 | 85 | 32.255; 32.291; 32.298 |  |
| 2202 | 955 | **Access Traffic Steering, Switch and Splitting support in the 5G system architecture** | 1568d? | 2017-06-05 A | 2023-06-06 A | 100% |  |  | 14576h | 14576h | ATSSS | 42 | So, Tricci, ZTE | tso@ztetx.com | Rel-16 | 82 | 23.501; 23.502; 23.503 |  |
| 2203 | 955.1 | Study on ATSSS | 400d? | 2017-06-05 A | 2018-12-14 A | 100% | finish no earlier than 2018-12-15 | S2 | 3200h | 3200h | FS_ATSSS | 39 | So, Tricci, ZTE | tso@ztetx.com | Rel-16 | 76 | new 23.793 |  |
| 2204 | 955.2 | Stage 2 of ATSSS | 136d | 2018-12-14 A | 2019-06-21 A | 100% | start no earlier than 2018-12-14 | S2 | 1088h | 1088h | ATSSS | 42 | So, Tricci, ZTE | tso@ztetx.com | Rel-16 | 82 | 23.501; 23.502; 23.503 |  |
| 2205 | 955.3 | **CT aspects of ATSSS** | 196d | 2019-03-11 A | 2019-12-09 A | 100% |  | ct | 8176h | 8176h | ATSSS | 42 | ZHOU, Xingyue (Joy), ZTE | zhou.xingyue@zte.com.cn | Rel-16 | 83 |  |  |
| 2206 | 955.3.1 | CT1 aspects of ATSSS | 196d | 2019-03-11 A | 2019-12-09 A | 100% | start no earlier than 2019-03-11 | C1 | 1568h | 1568h | ATSSS | 42 | ZHOU, Xingyue (Joy), ZTE | zhou.xingyue@zte.com.cn | Rel-16 | 83 | 24.501; 24.526; 24.502 |  |
| 2207 | 955.3.2 | CT3 aspects of ATSSS | 196d | 2019-03-11 A | 2019-12-09 A | 100% | start no earlier than 2019-03-11 | C3 | 1568h | 1568h | ATSSS | 42 | ZHOU, Xingyue (Joy), ZTE | zhou.xingyue@zte.com.cn | Rel-16 | 83 | 29.512; 29.513 |  |
| 2208 | 955.3.3 | CT4 aspects of ATSSS | 196d | 2019-03-11 A | 2019-12-09 A | 100% | start no earlier than 2019-03-11 | C4 | 1568h | 1568h | ATSSS | 42 | ZHOU, Xingyue (Joy), ZTE | zhou.xingyue@zte.com.cn | Rel-16 | 83 | 29.244; 29.502; 29.503; 29.505; 29.518; 29.510; 23.008 |  |
| 2209 | 955.3.4 | (IETF) TCP Extensions for Multipath Operation with Multiple Addresses (draft-ietf-mptcp-rfc6824bis) | 119d | 2019-06-26 A | 2019-12-09 A | 100% | finish no earlier than 2019-12-09 | S2-IETF | 952h | 952h | ATSSS | 43 |  |  | Rel-16 | 84 | RFC 8684 |  |
| 2210 | 955.3.5 | (IETF) 0-RTT TCP Convert Protocol (draft-ietf-tcpm-converters) | 119d | 2019-06-26 A | 2019-12-09 A | 100% | finish no earlier than 2019-12-09 | S2-IETF | 952h | 952h | ATSSS | 43 |  |  | Rel-16 | 84 | RFC 8803 |  |
| 2211 | 955.4 | Charging Access of ATSSS | 70d | 2019-12-06 A | 2020-03-12 A | 100% | finish no earlier than 2020-03-12 | S5 | 560h | 560h | ATSSS | 44 | Gardella, Maryse, Nokia | maryse.gardella@nokia.com | Rel-16 | 86 | 32.255; 32.290; 32.291; 32.298 |  |
| 2212 | 955.5 | UE Conformance Test Aspects - Access Traffic Steering, Switch and Splitting support in 5G system | 194d | 2022-09-08 A | 2023-06-06 A | 100% | finish no earlier than 2023-12-12 | R5 | 1552h | 1552h | ATSSS-UEConTest | 49 | Jing Zhao, China telecom | Zhaoj16@chinatelecom.cn | Rel-16 | 97 |  | RP-230078 |

Notes:
- 2190: 31/5/19: 0%->80; 13/9/19: 80%->95; 6/12/19: 95%->98; 26/3/20: 98%->100
- 2191: 13/9/19: 0%->95; 26/3/20: 95%->100
- 2192: 6/12/19: 0%->100
- 2193: 31/5/19: 0%->10; 26/3/20: 10%->100
- 2194: ; 6/12/19: 0%->100
- 2196: 15/12/17: 23.726 added;¦16/3/18: 0%->25¦7/6/18: 25%->40¦10/9/18: 40%->65¦10/9/18: FCD:09/18->12/18¦2/10/18: WID:SP-170743->SP-180731¦2/10/18: FCD:12/18->12/18¦7/12/18: 65%->100
- 2197: 14/3/19: 0%->45; 31/5/19: 45%->90; 13/9/19: 90%->100
- 2199: 13/9/19: 0%->80; 6/12/19: 80%->85; 26/3/20: 85%->100
- 2200: 31/5/19: 0%->25; 13/9/19: 25%->95; 6/12/19: 95%->100
- 2201: ; 6/12/19: 0%->70; 26/3/20: 70%->100
- 2203: 11/9/17: 0%->100¦14/9/17: 100%->10¦15/12/17: Changed Rel-15->Rel-16¦16/3/18: 10%->20¦7/6/18: 20%->40¦10/9/18: 40%->70¦10/9/18: FCD:09/18->12/18¦2/10/18: WID:SP-170411->SP-180732¦2/10/18: FCD:12/18->12/18¦7/12/18: 70%->100
- 2204: 14/3/19: 0%->45; 31/5/19: 45%->85; 13/9/19: 85%->100
- 2206: 31/5/19: 0%->25; 13/9/19: 25%->55; 6/12/19: 55%->65; 26/3/20: 65%->70; 26/6/20: 70%->100
- 2207: 31/5/19: 0%->50; 13/9/19: 50%->55; 6/12/19: 55%->60; 26/3/20: 60%->100
- 2208: 31/5/19: 0%->25; 13/9/19: 25%->45; 6/12/19: 45%->75; 26/3/20: 75%->85; 26/6/20: 85%->100
- 2209: 23/4/20: 80%->100; 9/4/21: RFC 8684 added;
- 2210: 23/4/20: 30%->90; 25/9/20: 90%->100; 9/4/21: RFC 8803 added;
- 2211: ; 26/3/20: 0%->15; 28/6/20: 15%->70; 13/9/20: 70%->100
- 2212: 9/12/22: FCD:10/12/2023->01/12/2023; Compl:0%->5%; Stat Rep: ->RP-222738; Rapporteur: China Telecom->Jing Zhao, China telecom; Rap eMail: ->Zhaoj16@chinatelecom.cn; 17/3/23: FCD:30/11/2023->12/12/2023; Compl:5%->55%; Stat Rep: RP-222738->RP-230078; ...

| ID | WBS | Task | Type | Duration | Start | Finish | Complete | Actual finish | Constraint | Resources | Work | Actual work | Acronym | PCG approved | WI rapporteur name | WI rapporteur e-mail | Release | TSG approved |
| --- | --- | --- | --- | --- | --- | --- | --- | --- | --- | --- | --- | --- | --- | --- | --- | --- | --- | --- |
| 2213 | 956 | **Single radio voice continuity from 5GS to 3G** |  | 977d? | 2018-03-15 A | 2021-12-10 A | 100% |  |  |  | 18480h | 18480h | 5G_SRVCC | 41 | Chi Ren, China Unicom | renchi1@chinaunicom.cn | Rel-16 | 81 |
| 2214 | 956.1 | Study for single radio voice continuity from 5GS to 3G |  | 67d? | 2018-03-15 A | 2018-06-15 A | 100% |  | finish no earlier than 2018-06-15 | S2 | 536h | 536h | FS_5G-SRVCC | 40 | Chi Ren, China Unicom | renchi1@chinaunicom.cn | Rel-16 | 79 |
| 2215 | 956.2 | Single radio voice continuity from 5GS to 3G |  | 136d? | 2018-09-06 A | 2019-03-14 A | 100% |  | finish no earlier than 2019-03-14 | S2 | 1088h | 1088h | 5G_SRVCC | 41 | Chi Ren, China Unicom | renchi1@chinaunicom.cn | Rel-16 | 81 |
| 2216 | 956.3 | Security aspects of single radio voice continuity from 5GS to UTRAN |  | 130d | 2018-12-13 A | 2019-06-12 A | 100% |  | start no earlier than 2018-12-13 | S3 | 1040h | 1040h | 5GS_UTRAN_SEC | 42 | Feng Gao, China Unicom | gaofeng149@chinaunicom.cn | Rel-16 | 82 |
| 2217 | 956.4 | **RAN aspects of 5G_SRVCC** |  | 262d | 2018-12-15 A | 2019-12-15 | 100% | 2021-12-10 |  | R2 | 9384h | 9384h | SRVCC_NR_to_UMTS | 42 | China Unicom |  | Rel-16 | 82 |
| 2218 | 956.4.1 | Core part: Single Radio Voice Call Continuity from 5G to 3G | manual | 262d | 2018-12-15 A | 2019-12-15 A | 100% |  |  | R2 | 2096h | 2096h | SRVCC_NR_to_UMTS-Core | 42 | China Unicom |  | Rel-16 | 82 |
| 2219 | 956.4.2 | Perf. part: Single Radio Voice Call Continuity from 5G to 3G |  | 327d | 2019-03-01 A | 2020-06-01 A | 100% |  | finish no earlier than 2020-06-01 | R4 | 2616h | 2616h | SRVCC_NR_to_UMTS-Perf | 42 | China Unicom |  | Rel-16 | 83 |
| 2220 | 956.4.3 | UE Conformance Test Aspects - Single Radio Voice Call Continuity from 5G to 3G |  | 322d | 2020-09-17 A | 2021-12-10 A | 100% |  | finish no earlier than 2021-12-12 | R5 | 2576h | 2576h | SRVCC_NR_to_UMTS-UEConTest | 45 | China Unicom |  | Rel-16 | 89 |
| 2221 | 956.5 | **CT aspect of 5G_SRVCC** |  | 201d | 2019-06-06 A | 2020-03-12 A | 100% |  |  | ct | 6432h | 6432h | 5G_SRVCC | 43 | Chi Ren, China Unicom | renchi1@chinaunicom.cn | Rel-16 | 84 |
| 2222 | 956.5.1 | CT1 aspect of 5G_SRVCC |  | 201d | 2019-06-06 A | 2020-03-12 A | 100% |  | finish no earlier than 2020-03-12 | C1 | 1608h | 1608h | 5G_SRVCC | 43 | Chi Ren, China Unicom | renchi1@chinaunicom.cn | Rel-16 | 84 |
| 2223 | 956.5.2 | CT3 aspect of 5G_SRVCC |  | 201d | 2019-06-06 A | 2020-03-12 A | 100% |  | finish no earlier than 2020-03-12 | C3 | 1608h | 1608h | 5G_SRVCC | 44 | Chi Ren, China Unicom | renchi1@chinaunicom.cn | Rel-16 | 86 |
| 2224 | 956.5.3 | CT4 aspect of 5G_SRVCC |  | 201d | 2019-06-06 A | 2020-03-12 A | 100% |  | finish no earlier than 2020-03-12 | C4 | 1608h | 1608h | 5G_SRVCC | 43 | Chi Ren, China Unicom | renchi1@chinaunicom.cn | Rel-16 | 84 |
| 2225 | 957 | Study on Remote Identification of Uncrewed Aerial Systems |  | 132d? | 2018-03-15 A | 2018-09-14 A | 100% |  | finish no earlier than 2018-09-14 | S1 | 1056h | 1056h | FS_ID_UAS | 40 | Eddy Hall; Qualcomm Incorporated | edhall@qti.qualcomm.com | Rel-16 | 79 |
| 2226 | 958 | Study on Security Aspects of the 5G Service Based Architecture |  | 462d? | 2018-06-06 A | 2020-03-12 A | 100% |  | finish no earlier than 2020-03-12 | S3 | 3696h | 3696h | FS_SBA_Sec | 41 | Hans Christian Rudolph, Deutsche Telekom AG | hans-christian.rudolph@telekom.de | Rel-16 | 80 |
| 2227 | 959 | **Enhancements to the Service-Based 5G System Architecture** |  | 587d? | 2018-03-15 A | 2020-06-12 A | 100% |  |  |  | 8904h | 8904h | 5G_eSBA | 42 |  |  | Rel-16 | 82 |
| 2228 | 959.1 | Study on Enhancements to the Service-Based 5G System Architecture |  | 197d? | 2018-03-15 A | 2018-12-14 A | 100% |  | finish no earlier than 2018-12-14 | S2 | 1576h | 1576h | FS_eSBA | 40 | Tao Sun (China Mobile) | suntao@chinamobile.com | Rel-16 | 79 |
| 2229 | 959.2 | Stage 2 of 5G_eSBA |  | 136d | 2018-12-13 A | 2019-06-20 A | 100% |  | start no earlier than 2018-12-13 | S2 | 1088h | 1088h | 5G_eSBA | 42 | Tao Sun (China Mobile) | suntao@chinamobile.com | Rel-16 | 82 |
| 2230 | 959.3 | **CT aspects of 5G_eSBA** |  | 196d | 2019-03-14 A | 2019-12-12 A | 100% |  |  | ct | 4704h | 4704h | 5G_eSBA | 42 | Song Yue (China Mobile) | songyue at chinamobile dot com | Rel-16 | 83 |
| 2231 | 959.3.1 | CT3 aspects of 5G_eSBA |  | 196d | 2019-03-14 A | 2019-12-12 A | 100% |  | start no earlier than 2019-03-14 | C3 | 1568h | 1568h | 5G_eSBA | 42 | Song Yue (China Mobile) | songyue at chinamobile dot com | Rel-16 | 83 |
| 2232 | 959.3.2 | CT4 aspects of 5G_eSBA |  | 196d | 2019-03-14 A | 2019-12-12 A | 100% |  | start no earlier than 2019-03-14 | C4 | 1568h | 1568h | 5G_eSBA | 42 | Song Yue (China Mobile) | songyue at chinamobile dot com | Rel-16 | 83 |
| 2233 | 959.4 | Security for 5G_eSBA |  | 192d | 2019-09-19 A | 2020-06-12 A | 100% |  | finish no earlier than 2020-06-12 | S3 | 1536h | 1536h | 5G_eSBA | 43 | Nagendra Bykampadi, Nokia | nagendra.bykampadi@nokia.com | Rel-16 | 85 |
| 2234 | 960 | Study on Enhanced IMS to 5GC Integration |  | 391d? | 2017-12-15 A | 2019-06-14 A | 100% |  | finish no earlier than 2019-06-14 | S2 | 3128h | 3128h | FS_eIMS5G | 40 | Joul, Chris, T-Mobile USA | chris <dot> joul <at> t-mobile <dot> com | Rel-16 | 78 |
| 2235 | 961 | **SBA aspects of enhanced IMS to 5GC integration** |  | 66d | 2019-03-14 A | 2019-06-13 | 100% | 2020-03-12 |  |  | 6959h | 6959h | eIMS5G_SBA | 42 | T-Mobile USA, Christopher Joul |  | Rel-16 | 84 |
| 2236 | 961.1 | Stage 2 of eIMS5G_SBA | manual | 65.88d | 2019-03-14 A | 2019-06-13 A | 100% |  |  | S2 | 527h | 527h | eIMS5G_SBA | 42 | T-Mobile USA, Christopher Joul |  | Rel-16 | 83 |

Notes:
- 2213: Impacted TSs and TRs: 23.216; 23.501; 23.502
- 2214: 7/6/18: 0%->80¦6/8/18: 23.756 added;¦10/9/18: 80%->100 / Impacted TSs and TRs: 23.756
- 2215: 14/3/19: 0%->100 / Impacted TSs and TRs: 23.216; 23.501; 23.502
- 2216: 20/3/19: 0%->20; 13/9/19: 20%->100; 20/9/19: WID:SP-181037->SP-190703 / Impacted TSs and TRs: 33.501; 33.401; 33.220
- 2217: no Perf. part¦26/3/19: WID:RP-182811->RP-190713; 26/3/20: WID:RP-190713->RP-200151
- 2218: no Perf. part¦26/3/19: WID:RP-182811->RP-190713; 26/3/20: 0%->100
- 2219: 28/7/20: 0%->100
- 2220: tested: REL-16 WI SRVCC_NR_to_UMTS-Core ; 7/4/21: WID:RP-201794->RP-210400; 8/4/21: 0%->31; 8/4/21: FCD:08/09/2021->09/21; 2/7/21: FCD:Fri 10/09/->12/21; 2/7/21: 31%->85; 6/1/22: 85%->100
- 2221: 6/12/19: WID:CP-191062->CP-193014
- 2222: 13/9/19: 0%->65; 6/12/19: 65%->90; 26/3/20: 90%->100 / Impacted TSs and TRs: 24.501; 24.237; 24.008; 27.007
- 2223: 6/12/19: created, 0%->60; 26/3/20: 60%->100
- 2224: 13/9/19: 0%->60; 6/12/19: 60%->80; 26/3/20: 80%->100 / Impacted TSs and TRs: 29.303; 29.503; 29.504; 29.505; 29.518; 29.274
- 2225: 7/6/18: 0%->60¦10/9/18: 60%->100 / Impacted TSs and TRs: 22.825
- 2226: 6/8/18: 33.855 added;¦10/9/18: 65%->75¦7/12/18: 75%->76¦20/3/19: 76%->65¦20/3/19: FCD:018->09/19; 31/5/19: 65%->75; 13/9/19: FCD:12/09/2019->12/20; 13/9/19: 75%->80; 6/12/19: 80%->85; 6/12/19: FCD:12/12/2019->03/20; 26/6/20: 85%->100 / Impacted TSs and TRs: New; 33.855
- 2228: 7/6/18: 0%->15¦6/8/18: 23.742 added;¦10/9/18: 15%->60¦7/12/18: 60%->100 / Impacted TSs and TRs: 23.xxx; 23.742
- 2229: 14/3/19: 0%->50; 31/5/19: 50%->80; 13/9/19: 80%->100 / Impacted TSs and TRs: 23.501; 23.502; 23.503
- 2231: 6/12/19: 0%->30; 26/3/20: 30%->100 / Impacted TSs and TRs: 29.507; 29.508; 29.513; 29.512; 29.514; 29.519; 29.520; 29.521; 29.523; 29.525; 29.551; 29.554
- 2232: 31/5/19: 0%->10; 13/9/19: 10%->40; 6/12/19: 40%->70; 26/3/20: 70%->95; 26/6/20: 95%->100 / Impacted TSs and TRs: 29.500; 29.501; 29.502; 29.503; 29.504; 29.505; 29.509; 29.510; 29.511; 29.518; 29.531; 29.540; 29.571; 29.572; 29.573
- 2233: ; 6/12/19: 0%->45; 6/12/19: FCD:12/12/2019->03/20; 25/3/20: 45%->70; 25/3/20: FCD:12/03/2020->06/20; 26/6/20: 70%->95; 12/9/20: 95%->100 / Impacted TSs and TRs: 33.501
- 2234: 16/3/18: 0%->20¦7/6/18: 20%->40¦10/9/18: FCD:09/18->06/19¦2/10/18: WID:SP-171052->SP-180736¦14/3/19: 40%->70; 6/12/19: 70%->100 / Impacted TSs and TRs: new 23.794
- 2235: Impacted TSs and TRs: 23.501; 23.502; 23.503; 23.228
- 2236: 31/5/19: 0%->100 / Impacted TSs and TRs: 23.501; 23.502; 23.503; 23.228

| ID | WBS | Task | Type | Duration | Start | Finish | Complete | Remaining | Actual start | Actual finish | Total slack | Constraint | Resources | Work | Actual work | Acronym | PCG approved | WI rapporteur name | WI rapporteur e-mail | Release | TSG approved | Impacted TSs and TRs | Status Report |
| --- | --- | --- | --- | --- | --- | --- | --- | --- | --- | --- | --- | --- | --- | --- | --- | --- | --- | --- | --- | --- | --- | --- | --- |
| 2237 | 961.2 | **CT aspects of eIMS5G_SBA** |  | 201d | 2019-06-06 A | 2020-03-12 A | 100% |  |  |  |  |  | ct | 6432h | 6432h | eIMS5G_SBA | 43 | de Gregorio, Jesus. Ericsson | jesus.de.gregorio@ericsson.com | Rel-16 | 84 |  |  |
| 2238 | 961.2.1 | CT1 aspects of eIMS5G_SBA |  | 201d | 2019-06-06 A | 2020-03-12 A | 100% |  |  |  |  | finish no earlier than 2020-03-12 | C1 | 1608h | 1608h | eIMS5G_SBA | 43 | de Gregorio, Jesus. Ericsson | jesus.de.gregorio@ericsson.com | Rel-16 | 85 |  |  |
| 2239 | 961.2.2 | CT3 aspects of eIMS5G_SBA |  | 201d | 2019-06-06 A | 2020-03-12 A | 100% |  |  |  |  | finish no earlier than 2020-03-12 | C3 | 1608h | 1608h | eIMS5G_SBA | 43 | de Gregorio, Jesus. Ericsson | jesus.de.gregorio@ericsson.com | Rel-16 | 84 | 29.513; 29.514 |  |
| 2240 | 961.2.3 | CT4 aspects of eIMS5G_SBA |  | 201d | 2019-06-06 A | 2020-03-12 A | 100% |  |  |  |  | finish no earlier than 2020-03-12 | C4 | 1608h | 1608h | eIMS5G_SBA | 43 | de Gregorio, Jesus. Ericsson | jesus.de.gregorio@ericsson.com | Rel-16 | 84 | 29.510; 29.571; 23.380 |  |
| 2241 | 962 | **Private Network Support for NG-RAN** |  | 995d | 2019-03-01 A | 2022-12-21 | 99% | 0d |  |  | 0d |  | R3 | 15280h | 10746.3h | NG_RAN_PRN | 42 | China Telecom |  | Rel-16 | 83 |  |  |
| 2242 | 962.1 | Core part: Private Network Support for NG-RAN |  | 261d | 2019-03-01 A | 2020-02-28 A | 100% |  |  |  |  | finish no earlier than 2020-03-01 | R3 | 2088h | 2088h | NG_RAN_PRN-Core | 42 | China Telecom |  | Rel-16 | 83 |  |  |
| 2243 | 962.2 | UE Conformance Test Aspects - Private Network Support for NG-RAN |  | 654d | 2020-06-22 A | 2022-12-21 A | 100% |  |  |  |  | finish no earlier than 2022-12-22 | R5 | 5232h | 5232h | NG_RAN_PRN_Vertical_LAN-UEConTest | 45 | Yogesh Tugnawat, Qualcomm | yogesht[at]qti.qualcomm.com | Rel-16 | 88 |  | RP-221246 |
| 2244 | 963 | **Media Handling Aspects of RAN Delay Budget Reporting in MTSI** |  | 520d? | 2017-12-15 A | 2019-12-12 A | 100% |  |  |  |  |  |  | 9416h | 9416h | E2E_DELAY | 41 | Oyman, Ozgur, Company: Intel | ozgur.oyman@intel.com | Rel-16 | 81 | 26.114 |  |
| 2245 | 963.1 | Study on E2E_DELAY |  | 196d? | 2017-12-15 A | 2018-09-14 A | 100% |  |  |  |  | finish no earlier than 2018-09-14 | S4 | 1568h | 1568h | FS_E2E_DELAY | 40 | Oyman, Ozgur, Company: Intel, | ozgur.oyman@intel.com | Rel-16 | 78 | new |  |
| 2246 | 963.2 | Stage 2 of E2E_DELAY |  | 197d? | 2018-09-06 A | 2019-06-07 A | 100% |  |  |  |  | finish no earlier than 2019-06-07 | S4 | 1576h | 1576h | E2E_DELAY | 41 | Oyman, Ozgur, Company: Intel | ozgur.oyman@intel.com | Rel-16 | 81 | 26.114 |  |
| 2247 | 963.3 | **CT Aspects of E2E_DELAY** |  | 196d? | 2019-03-14 A | 2019-12-12 A | 100% |  |  |  |  |  | ct | 6272h | 6272h | E2E_DELAY | 42 | Luetzenkirchen, Thomas, Intel | Thomas.luetzenkirchen@intel.com | Rel-16 | 83 |  |  |
| 2248 | 963.3.1 | CT1 Aspects of E2E_DELAY |  | 196d? | 2019-03-14 A | 2019-12-12 A | 100% |  |  |  |  | finish no earlier than 2019-12-12 | C1 | 1568h | 1568h | E2E_DELAY | 42 | Luetzenkirchen, Thomas, Intel | Thomas.luetzenkirchen@intel.com | Rel-16 | 83 | 24.229 |  |
| 2249 | 963.3.2 | CT3 Aspects of E2E_DELAY |  | 196d? | 2019-03-14 A | 2019-12-12 A | 100% |  |  |  |  | finish no earlier than 2019-12-12 | C3 | 1568h | 1568h | E2E_DELAY | 42 | Luetzenkirchen, Thomas, Intel | Thomas.luetzenkirchen@intel.com | Rel-16 | 83 | 29.162 |  |
| 2250 | 963.3.3 | CT4 Aspects of E2E_DELAY |  | 196d? | 2019-03-14 A | 2019-12-12 A | 100% |  |  |  |  | finish no earlier than 2019-12-12 | C4 | 1568h | 1568h | E2E_DELAY | 42 | Luetzenkirchen, Thomas, Intel | Thomas.luetzenkirchen@intel.com | Rel-16 | 83 | 23.334; 29.334; 29.238; 23.333; 29.333 |  |
| 2251 | 964 | **Enhancements for Common API Framework for 3GPP Northbound APIs** |  | 521d? | 2018-03-15 A | 2020-03-12 A | 100% |  |  |  |  |  |  | 5216h | 5216h | eCAPIF | 42 | Basavaraj Pattan, Samsung | basavarajjp@samsung.com | Rel-16 | 83 | 23.222 |  |
| 2252 | 964.1 | Stage 2 for eCAPIF |  | 325d? | 2018-03-15 A | 2019-06-12 A | 100% |  |  |  |  | finish no earlier than 2019-06-12 | S6 | 2600h | 2600h | eCAPIF | 40 | Basavaraj Pattan, Samsung | basavarajjp@samsung.com | Rel-16 | 79 | 23.222 |  |
| 2253 | 964.2 | Security aspects of eCAPIF |  | 201d | 2019-03-07 A | 2019-12-12 A | 100% |  |  |  |  | finish no earlier than 2019-12-12 | S3 | 1608h | 1608h | eCAPIF | 42 | Rajavelsamy Rajadurai, Samsung | rajvel{@]samsung.com | Rel-16 | 83 | 33.122 |  |
| 2254 | 964.3 | CT aspects of eCAPIF |  | 126d | 2019-09-19 A | 2020-03-12 A | 100% |  |  |  |  | finish no earlier than 2020-03-12 | C3 | 1008h | 1008h | eCAPIF | 43 | Narendranath Durga, Tangudu (Samsung) | n.tangudu {@]samsung.com | Rel-16 | 85 | 29.222 |  |
| 2255 | 965 | **User data interworking, Coexistence and Migration** |  | 66.88d? | 2019-03-14 | 2019-06-14 | 100% |  | 2018-06-15 | 2020-03-12 |  |  | S2 | 4750h | 4750h | UDICOM | 42 | Alessio Casati, Nokia | Alessio.casati@nokia.com | Rel-16 | 84 | 23.501; 23.502; 23.228 |  |
| 2256 | 965.1 | Study on UDICOM |  | 259d? | 2018-06-15 A | 2019-06-12 A | 100% |  |  |  |  | finish no earlier than 2019-06-12 | S2 | 2072h | 2072h | FS_UDICoM | 41 | Susana Sabater (Vodafone | susana.sabater@vodafone.com | Rel-16 | 80 | 23.732; new |  |
| 2257 | 965.2 | Stage 2 of UDICOM | manual | 66.88d | 2019-03-14 A | 2019-06-14 A | 100% |  |  |  |  |  | S2 | 535h | 535h | UDICOM | 42 | Alessio Casati, Nokia | Alessio.casati@nokia.com | Rel-16 | 83 | 23.501; 23.502; 23.228; 23.632 |  |
| 2258 | 965.3 | CT aspects of UDICOM |  | 201d | 2019-06-06 A | 2020-03-12 A | 100% |  |  |  |  | finish no earlier than 2020-03-12 | C4 | 1608h | 1608h | UDICOM | 43 | Wiehe, Ulrich, Nokia | ulrich.wiehe@nokia.com | Rel-16 | 84 | 29.503; 29.505; 29.571; 29.510 |  |
| 2259 | 966 | UICC-terminal interface testing for UEs with non-removable UICCs |  | 257d | 2021-03-18 A | 2022-03-10 | 80% | 51.4d |  |  | 1041d | finish no earlier than 2022-03-11 | C6 | 2056h |  | nrUICC_UEConTest | 46 | Marquordt, Arne, COMPRION GmbH | amarquordt@comprion.com | Rel-16 | 91 | 31.122; 31.213 |  |
| 2260 | 967 | Study on authentication and key management for applications based on 3GPP credential in 5G |  | 397d? | 2018-06-06 A | 2019-12-12 A | 100% |  |  |  |  | finish no earlier than 2019-12-12 | S3 | 3176h | 3176h | FS_AKMA | 41 | Jin Peng, China Mobile | pengjin@chinamobile.com | Rel-16 | 80 | New; 33.835 |  |
| 2261 | 968 | Removal of AKMA from Rel-16 |  | 6d | 2020-12-04 A | 2020-12-11 A | 100% |  |  |  |  | finish no earlier than 2020-12-12 | S3 | 48h | 48h | RM_AKMA_R16 | 46 | Xiaoting Huang, China Mobile | huangxiaoting@chinamobile.com | Rel-16 | 90 |  |  |
| 2262 | 969 | NR-related Release 16 Features | milestone | 0d? | 2019-03-07 A | 2019-03-07 A | 100% |  |  |  |  |  |  |  |  |  |  |  |  | Rel-16 |  |  |  |

Notes:
- 2237: 16/9/19: WID:CP-191065->CP-192023
- 2238: 6/12/19: 0%->70; 26/6/20: 70%->100
- 2239: 13/9/19: 0%->70; 6/12/19: 70%->90; 26/3/20: 90%->100
- 2240: 13/9/19: 0%->25; 6/12/19: 25%->50; 26/3/20: 50%->90; 26/6/20: 90%->100
- 2241: 26/3/20: WID:RP-190729->RP-200122
- 2242: 26/6/19: WID:RP-190729->RP-191563; 28/7/20: 0%->100
- 2243: 8/10/20: 0%->5; 8/4/21: 5%->10; 2/7/21: 10%->31; 20/6/22: FCD:15/12/2021->22/12/2022; Compl:31%->89%; Stat Rep: ->RP-221246; Rapporteur: Qualcomm->Yogesh Tugnawat, Qualcomm; Rap eMail: ->yogesht[at]qti.qualcomm.com 9/9/22: Compl:89%->97%; 29/3/23: 97%->100
- 2245: 16/3/18: 0%->10¦7/6/18: 10%->60¦10/9/18: 60%->100
- 2246: 7/12/18: 0%->75¦7/3/19: 75%->85¦7/3/19: FCD:03/19->06/19; 31/5/19: 85%->100
- 2248: 31/5/19: 0%->100; 13/9/19: 100%->100
- 2249: 31/5/19: 0%->100
- 2250: 31/5/19: 0%->100
- 2251: 7/6/18: 0%->15¦10/9/18: 15%->30¦7/12/18: 30%->45¦7/12/18: FCD:12/18->06/19¦13/12/18: WID:SP-180161->SP-181137
- 2252: 7/6/18: 0%->15¦10/9/18: 15%->30¦7/12/18: 30%->45¦7/12/18: FCD:12/18->06/19¦13/12/18: WID:SP-180161->SP-181137¦14/3/19: 45%->80; 31/5/19: 80%->100
- 2253: 31/5/19: 0%->30; 31/5/19: 0%->30; 31/5/19: 0%->30; 13/9/19: 30%->90; 13/9/19: FCD:13/09/2019->12/20; 6/12/19: 90%->100
- 2254: ; 6/12/19: 0%->65; 26/3/20: 65%->95; 26/6/20: 95%->100
- 2256: 10/9/18: 0%->30¦2/10/18: WID:SP-180620->SP-180735¦7/12/18: 30%->80¦14/12/18: FCD:12/18->03/20¦14/3/19: 80%->100¦21/3/19: WID:SP-181110->SP-190148¦21/3/19: FCD:019->06/19; 13/9/19: 75%->100
- 2257: 6/6/19: 0%->100; 26/6/19: 23.632 added;
- 2258: 31/5/19: 0%->10; 13/9/19: 10%->25; 6/12/19: 25%->75; 9/12/19: WID:CP-191066->CP-193016; 26/3/20: 75%->90; 26/6/20: 90%->100
- 2259: ; 21/3/21: 0%->5; 13/9/21: 5%->10; 13/9/21: FCD:Fri 10/12/->03/22; 4/6/22: 10%->15; 6/6/23: Compl:45%->60%
- 2260: 6/8/18: 33.835 added;¦7/12/18: 5%->20¦20/3/19: 20%->60¦20/3/19: FCD:019->09/19; 13/9/19: 60%->70; 13/9/19: FCD:12/09/2019->12/19; 6/12/19: 70%->95; 26/6/20: 95%->100
- 2261: 33.535; 33.501; 33.220 ; 9/4/21: 0%->100
- 2262: -

| ID | WBS | Task | Duration | Start | Finish | Complete | Remaining | Total slack | Constraint | Resources | Work | Actual work | Acronym | PCG approved | Release | TSG approved | Status Report | Impacted TSs and TRs |
| --- | --- | --- | --- | --- | --- | --- | --- | --- | --- | --- | --- | --- | --- | --- | --- | --- | --- | --- |
| 2263 | 970 | **Addition of wider channel bandwidth in NR band n3** | 65d | 2019-12-16 A | 2020-03-13 A | 100% |  |  |  | R4 | 1560h | 1560h | NR_n3_BW | 44 | Rel-16 | 86 |  |  |
| 2264 | 970.1 | Core part: Addition of wider channel bandwidth in NR band n3 | 65d | 2019-12-16 A | 2020-03-13 A | 100% |  |  | finish no earlier than 2020-03-15 | R4 | 520h | 520h | NR_n3_BW-Core | 44 | Rel-16 | 86 |  |  |
| 2265 | 970.2 | Perf. part: Addition of wider channel bandwidth in NR band n3 | 65d | 2019-12-16 A | 2020-03-13 A | 100% |  |  | finish no earlier than 2020-03-15 | R4 | 520h | 520h | NR_n3_BW-Perf | 44 | Rel-16 | 86 |  |  |
| 2266 | 971 | **Addition of wider channel bandwidth in NR band n65** | 65d | 2019-12-16 A | 2020-03-13 A | 100% |  |  |  | R4 | 1560h | 1560h | NR_n65_BW | 44 | Rel-16 | 86 |  |  |
| 2267 | 971.1 | Core part: Addition of wider channel bandwidth in NR band n65 | 65d | 2019-12-16 A | 2020-03-13 A | 100% |  |  | finish no earlier than 2020-03-15 | R4 | 520h | 520h | NR_n65_BW-Core | 44 | Rel-16 | 86 |  |  |
| 2268 | 971.2 | Perf. part: Addition of wider channel bandwidth in NR band n65 | 65d | 2019-12-16 A | 2020-03-13 A | 100% |  |  | finish no earlier than 2020-03-15 | R4 | 520h | 520h | NR_n65_BW-Perf | 44 | Rel-16 | 86 |  |  |
| 2269 | 972 | **UE Power Saving in NR** | 588d? | 2018-06-15 A | 2020-09-15 A | 100% |  |  |  | R1 | 12104h | 12104h | NR_UE_pow_sav | 42 | Rel-16 | 83 |  |  |
| 2270 | 972.1 | Study on UE power saving in NR | 261d? | 2018-06-15 A | 2019-06-14 A | 100% |  |  | finish no earlier than 2019-06-15 | R1 | 2088h | 2088h | FS_NR_UE_pow_sav | 41 | Rel-16 | 80 |  |  |
| 2271 | 972.2 | Core part: UE Power Saving in NR | 261d | 2019-03-01 A | 2020-02-28 A | 100% |  |  | finish no earlier than 2020-03-01 | R1 | 2088h | 2088h | NR_UE_pow_sav-Core | 42 | Rel-16 | 83 |  |  |
| 2272 | 972.3 | Perf. part: UE Power Saving in NR | 403d | 2019-03-01 A | 2020-09-15 A | 100% |  |  | finish no earlier than 2020-09-15 | R4 | 3224h | 3224h | NR_UE_pow_sav-Perf | 42 | Rel-16 | 83 |  |  |
| 2273 | 973 | **Band combinations for SA NR supplementary uplink (SUL), NSA NR SUL, NSA NR SUL with UL sharing from the UE perspective (ULSUP)** | 391d? | 2018-06-15 A | 2019-12-13 A | 100% |  |  |  | R4 | 9384h | 9384h | NR_SUL_combos_R16 | 41 | Rel-16 | 80 |  |  |
| 2274 | 973.1 | Core part: Band combinations for SA NR supplementary uplink (SUL), NSA NR SUL, NSA NR SUL with UL sharing from the UE perspective (ULSUP) | 391d? | 2018-06-15 A | 2019-12-13 A | 100% |  |  | finish no earlier than 2019-12-15 | R4 | 3128h | 3128h | NR_SUL_combos_R16-Core | 41 | Rel-16 | 80 |  |  |
| 2275 | 973.2 | Perf. part: Band combinations for SA NR supplementary uplink (SUL), NSA NR SUL, NSA NR SUL with UL sharing from the UE perspective (ULSUP) | 391d? | 2018-06-15 A | 2019-12-13 A | 100% |  |  | finish no earlier than 2019-12-15 | R4 | 3128h | 3128h | NR_SUL_combos_R16-Perf | 41 | Rel-16 | 80 |  |  |
| 2276 | 974 | **NR intra-band Carrier Aggregation** | 391d? | 2018-06-15 A | 2019-12-13 A | 100% |  |  |  |  | 18768h | 18768h |  | 41 | Rel-16 | 80 |  |  |
| 2277 | 974.1 | **Rel-16 NR intra band CA for xCC DL/yCC UL including contiguous and non-contiguous spectrum (x>=y)** | 391d? | 2018-06-15 A | 2019-12-13 A | 100% |  |  |  | R4 | 9384h | 9384h | NR_CA_R16_intra | 41 | Rel-16 | 80 |  |  |
| 2278 | 974.1.1 | Core part: Rel-16 NR intra band CA for xCC DL/yCC UL including contiguous and non-contiguous spectrum (x>=y) | 391d? | 2018-06-15 A | 2019-12-13 A | 100% |  |  | finish no earlier than 2019-12-15 | R4 | 3128h | 3128h | NR_CA_R16_intra-Core | 41 | Rel-16 | 80 |  |  |
| 2279 | 974.1.2 | Perf. part: Rel-16 NR intra band CA for xCC DL/yCC UL including contiguous and non-contiguous spectrum (x>=y) | 391d? | 2018-06-15 A | 2019-12-13 A | 100% |  |  | finish no earlier than 2019-12-15 | R4 | 3128h | 3128h | NR_CA_R16_intra-Perf | 41 | Rel-16 | 80 |  |  |
| 2280 | 974.2 | **Rel-16 NR inter-band CA/Dual Connectivity for 2 bands DL with x bands UL (x=1, 2)** | 391d? | 2018-06-15 A | 2019-12-13 A | 100% |  |  |  | R4 | 9384h | 9384h | NR_CADC_R16_2BDL_xBUL | 41 | Rel-16 | 80 |  |  |
| 2281 | 974.2.1 | Core part: Rel-16 NR inter-band CA/Dual Connectivity for 2 bands DL with x bands UL (x=1, 2) | 391d? | 2018-06-15 A | 2019-12-13 A | 100% |  |  | finish no earlier than 2019-12-15 | R4 | 3128h | 3128h | NR_CADC_R16_2BDL_xBUL-Core | 41 | Rel-16 | 80 |  |  |
| 2282 | 974.2.2 | Perf. part: Rel-16 NR inter-band CA/Dual Connectivity for 2 bands DL with x bands UL (x=1, 2) | 391d? | 2018-06-15 A | 2019-12-13 A | 100% |  |  | finish no earlier than 2019-12-15 | R4 | 3128h | 3128h | NR_CADC_R16_2BDL_xBUL-Perf | 41 | Rel-16 | 80 |  |  |
| 2283 | 975 | **NR inter-band Carrier Aggregation** | 1379d | 2019-03-01 A | 2024-06-06 | 73% | 376.72d | 453d |  |  | 23560h | 12528h |  | 42 | Rel-16 | 83 |  |  |
| 2284 | 975.1 | UE Conformance Test Aspects - Rel-16 NR CA and DC; and NR and LTE DC Configurations | 1379d | 2019-03-01 A | 2024-06-06 | 52% | 661.92d | 453d | finish no earlier than 2024-06-06 | R5 | 11032h |  | NR_CADC_NR_LTE_DC_R16-UEConTest | 42 | Rel-16 | 83 | RP-240145 |  |
| 2285 | 975.2 | **Rel16 NR inter-band Carrier Aggregation for 3 bands DL with 1 band UL** | 261d | 2019-03-01 A | 2020-02-28 A | 100% |  |  |  | R4 | 6264h | 6264h | NR_CA_R16_3BDL_1BUL | 42 | Rel-16 | 83 |  |  |
| 2286 | 975.2.1 | Core part: Rel16 NR inter-band Carrier Aggregation for 3 bands DL with 1 band UL | 261d | 2019-03-01 A | 2020-02-28 A | 100% |  |  | finish no earlier than 2020-03-01 | R4 | 2088h | 2088h | NR_CA_R16_3BDL_1BUL-Core | 42 | Rel-16 | 83 |  | 38.716-03-01 |
| 2287 | 975.2.2 | Perf. part: Rel16 NR inter-band Carrier Aggregation for 3 bands DL with 1 band UL | 261d | 2019-03-01 A | 2020-02-28 A | 100% |  |  | finish no earlier than 2020-03-01 | R4 | 2088h | 2088h | NR_CA_R16_3BDL_1BUL-Perf | 42 | Rel-16 | 83 |  |  |

Notes:
- 2263: affects: NR.; 26/3/20: WID:RP-193056->RP-200305 / WI rapporteur name: Ericsson
- 2264: affects: NR.; 28/7/20: 0%->100 / WI rapporteur name: Ericsson
- 2265: affects: NR.; 28/7/20: 0%->100 / WI rapporteur name: Ericsson
- 2266: affects: NR.; 26/3/20: WID:RP-193057->RP-200306 / WI rapporteur name: Ericsson
- 2267: affects: NR.; 28/7/20: 0%->100 / WI rapporteur name: Ericsson
- 2268: affects: NR.; 28/7/20: 0%->100 / WI rapporteur name: Ericsson
- 2269: 26/6/19: WID:RP-190727->RP-191607; 30/6/20: WID:RP-191607->RP-200494 / WI rapporteur name: CATT
- 2270: TR 38.8xx; 26/6/19: 0%->100 / WI rapporteur name: CATT
- 2271: 28/7/20: 0%->100 / WI rapporteur name: CATT
- 2272: 7/4/21: 0%->100 / WI rapporteur name: CATT
- 2273: basket WI¦TR 37.716-00-00¦note: WI covers for SA NR: 1 NR SUL band (already defined) + 1 or more NR bands and for NSA NR: 1 NR SUL band (already defined) + 1 or more NR bands + 1 or more LTE bands¦26/3/19: WID:RP-182559->RP-190714; 26/6/19: WID:RP-1907 / WI rapporteur name: Huawei
- 2274: basket WI¦TR 37.716-00-00¦note: WI covers for SA NR: 1 NR SUL band (already defined) + 1 or more NR bands and for NSA NR: 1 NR SUL band (already defined) + 1 or more NR bands + 1 or more LTE bands¦26/3/19: WID:RP-182559->RP-190714; 28/7/20: 0%->100 / WI rapporteur name: Huawei
- 2275: basket WI¦26/3/19: WID:RP-182559->RP-190714; 28/7/20: 0%->100 / WI rapporteur name: Huawei
- 2277: basket WI¦TR 38.716-01-01¦16/1/19: WID:RP-181426->RP-182256¦26/3/19: WID:RP-182256->RP-190689; 26/6/19: WID:RP-190689->RP-191194; 8/10/19: WID:RP-191194->RP-191812; 14/1/20: WID:RP-191812->RP-192445; 26/3/20: WID:RP-192445->RP-200101; 28/7/20: WID:RP-2 / WI rapporteur name: Ericsson
- 2278: basket WI¦TR 38.716-01-01¦26/3/19: WID:RP-182256->RP-190689; 28/7/20: 0%->100 / WI rapporteur name: Ericsson
- 2279: basket WI¦26/3/19: WID:RP-182256->RP-190689; 28/7/20: 0%->100 / WI rapporteur name: Ericsson
- 2280: basket WI¦TR 38.716-02-00¦16/1/19: WID:RP-180817->RP-182501¦26/3/19: WID:RP-182501->RP-190494; 26/6/19: WID:RP-190494->RP-191565; 8/10/19: WID:RP-191565->RP-191822; 14/1/20: WID:RP-191822->RP-192615; 26/3/20: WID:RP-192615->RP-200168; 28/7/20: WID:RP-2 / WI rapporteur name: ZTE
- 2281: basket WI¦TR 38.716-02-00¦26/3/19: WID:RP-182501->RP-190494; 28/7/20: 0%->100 / WI rapporteur name: ZTE
- 2282: basket WI¦26/3/19: WID:RP-182501->RP-190494; 28/7/20: 0%->100 / WI rapporteur name: ZTE
- 2284: 8/10/19: WID:RP-190321->RP-191772; 28/7/20: WID:RP-191772->RP-200759; 8/10/20: 0%->6; 8/10/20: FCD:01/06/2020->06/21; 8/4/21: 6%->6; 2/7/21: FCD:Fri 11/06/->12/21; 2/7/21: 6%->7 ; 22/3/22: Co ; 20/6/22: Rapporteur: CMCC->Dan SONG, Leif Mattisson, Y...; 14/3/24: FCD:05/06/2024->06/06/2024; Compl:50%->52%; Stat Rep: RP-233413->RP-240145; / WI rapporteur name: Luyang ZHAO, Kuba Kolodziej, Yu SHI, CMCC, Ericsson, China Unicom / WI rapporteur e-mail: zhaoluyang@chinamobile.com, kuba.kolodziej@ericsson.com, shiyu19@chinaunicom.cn
- 2285: 26/6/19: WID:RP-190692->RP-191153; 8/10/19: WID:RP-191153->RP-192245; 14/1/20: WID:RP-192245->RP-193206; 26/3/20: WID:RP-193206->RP-200238; 28/7/20: WID:RP-200238->RP-200918 / WI rapporteur name: CATT
- 2286: 26/6/19: 38.716-03-01 added;; 28/7/20: 0%->100 / WI rapporteur name: CATT
- 2287: 28/7/20: 0%->100 / WI rapporteur name: CATT

| ID | WBS | Task | Duration | Start | Finish | Complete | Remaining | Total slack | Constraint | Resources | Work | Actual work | Acronym | PCG approved | WI rapporteur name | Release | TSG approved | WI rapporteur e-mail | Status Report |
| --- | --- | --- | --- | --- | --- | --- | --- | --- | --- | --- | --- | --- | --- | --- | --- | --- | --- | --- | --- |
| 2288 | 975.3 | **Rel-16 NR Inter-band Carrier Aggregation/Dual Connectivity for 3 bands DL with 2 bands UL** | 261d | 2019-03-01 A | 2020-02-28 A | 100% |  |  |  | R4 | 6264h | 6264h | NR_CADC_R16_3BDL_2BUL | 42 | ZTE | Rel-16 | 83 |  |  |
| 2289 | 975.3.1 | Core part: Rel-16 NR Inter-band Carrier Aggregation/Dual Connectivity for 3 bands DL with 2 bands UL | 261d | 2019-03-01 A | 2020-02-28 A | 100% |  |  | finish no earlier than 2020-03-01 | R4 | 2088h | 2088h | NR_CADC_R16_3BDL_2BUL-Core | 42 | ZTE | Rel-16 | 83 |  |  |
| 2290 | 975.3.2 | Perf. part: Rel-16 NR Inter-band Carrier Aggregation/Dual Connectivity for 3 bands DL with 2 bands UL | 261d | 2019-03-01 A | 2020-02-28 A | 100% |  |  | finish no earlier than 2020-03-01 | R4 | 2088h | 2088h | NR_CADC_R16_3BDL_2BUL-Perf | 42 | ZTE | Rel-16 | 83 |  |  |
| 2291 | 976 | **New bands for New Radio** | 1166d? | 2018-06-15 A | 2022-12-01 | 99% | 0d? | 0d |  | R4 | 44816h | 36544h |  | 42 | Dish Network | Rel-16 | 83 |  |  |
| 2292 | 976.1 | UE Conformance Test Aspects for new Rel-16 NR bands and extension of existing NR bands | 836d | 2019-09-19 A | 2022-12-01 A | 100% |  |  | finish no earlier than 2022-12-01 | R5 | 6688h | 6688h | NR_bands_BW_R16-UEConTest | 43 | Leif MATTISSON, Ericsson | Rel-16 | 85 | Leif[dot]mattisson[at]ericsson[dot]com | RP-222816 |
| 2293 | 976.2 | **Band 65 for New Radio** | 131d? | 2018-06-15 A | 2018-12-14 A | 100% |  |  |  | R4 | 3144h | 3144h | NR_band_n65 | 41 | Dish Network | Rel-16 | 80 |  |  |
| 2294 | 976.2.1 | Core part: Band 65 for New Radio | 131d? | 2018-06-15 A | 2018-12-14 A | 100% |  |  | finish no earlier than 2018-12-15 | R4 | 1048h | 1048h | NR_band_n65-Core | 41 | Dish Network | Rel-16 | 80 |  |  |
| 2295 | 976.2.2 | Perf. part: Band 65 for New Radio | 131d? | 2018-06-15 A | 2018-12-14 A | 100% |  |  | finish no earlier than 2018-12-15 | R4 | 1048h | 1048h | NR_band_n65-Perf | 41 | Dish Network | Rel-16 | 80 |  |  |
| 2296 | 976.3 | **Introduction of NR band n18** | 262d | 2018-12-13 A | 2019-12-13 A | 100% |  |  |  | R4 | 6288h | 6288h | NR_n18 | 42 | KDDI | Rel-16 | 82 |  |  |
| 2297 | 976.3.1 | Core part: Introduction of NR band n18 | 262d | 2018-12-13 A | 2019-12-13 A | 100% |  |  | start no earlier than 2018-12-13 | R4 | 2096h | 2096h | NR_n18-Core | 42 | KDDI | Rel-16 | 82 |  |  |
| 2298 | 976.3.2 | Perf. part: Introduction of NR band n18 | 262d | 2018-12-13 A | 2019-12-13 A | 100% |  |  | start no earlier than 2018-12-13 | R4 | 2096h | 2096h | NR_n18-Perf | 42 | KDDI | Rel-16 | 82 |  |  |
| 2299 | 976.4 | **Introduction of NR band n48** | 122d | 2018-12-13 A | 2019-05-31 A | 100% |  |  |  | R4 | 2048h | 2048h | NR_n48 | 42 | US Cellular | Rel-16 | 82 |  |  |
| 2300 | 976.4.1 | Core part: Introduction of NR band n48 | 68d | 2018-12-13 A | 2019-03-18 A | 100% |  |  | start no earlier than 2018-12-13 | R4 | 544h | 544h | NR_n48-Core | 42 | US Cellular | Rel-16 | 82 |  |  |
| 2301 | 976.4.2 | Perf. part: Introduction of NR band n48 | 66d | 2019-03-01 A | 2019-05-31 A | 100% |  |  | finish no earlier than 2019-06-01 | R4 | 528h | 528h | NR_n48-Perf | 42 | Nokia | Rel-16 | 83 |  |  |
| 2302 | 976.5 | **Introduction of NR band n14** | 66d | 2019-03-01 A | 2019-05-31 A | 100% |  |  |  | R4 | 1584h | 1584h | NR_n14 | 42 | AT&T | Rel-16 | 83 |  |  |
| 2303 | 976.5.1 | Core part: Introduction of NR band n14 | 66d | 2019-03-01 A | 2019-05-31 A | 100% |  |  | finish no earlier than 2019-06-01 | R4 | 528h | 528h | NR_n14-Core | 42 | AT&T | Rel-16 | 83 |  |  |
| 2304 | 976.5.2 | Perf. part: Introduction of NR band n14 | 66d | 2019-03-01 A | 2019-05-31 A | 100% |  |  | finish no earlier than 2019-06-01 | R4 | 528h | 528h | NR_n14-Perf | 42 | AT&T | Rel-16 | 83 |  |  |
| 2305 | 976.6 | **Introduction of NR band n30** | 66d | 2019-03-01 A | 2019-05-31 A | 100% |  |  |  | R4 | 1584h | 1584h | NR_n30 | 42 | AT&T | Rel-16 | 83 |  |  |
| 2306 | 976.6.1 | Core part: Introduction of NR band n30 | 66d | 2019-03-01 A | 2019-05-31 A | 100% |  |  | finish no earlier than 2019-06-01 | R4 | 528h | 528h | NR_n30-Core | 42 | AT&T | Rel-16 | 83 |  |  |
| 2307 | 976.6.2 | Perf. part: Introduction of NR band n30 | 66d | 2019-03-01 A | 2019-05-31 A | 100% |  |  | finish no earlier than 2019-06-01 | R4 | 528h | 528h | NR_n30-Perf | 42 | AT&T | Rel-16 | 83 |  |  |
| 2308 | 976.7 | **Introduction of NR band n259** | 206d | 2019-03-01 A | 2019-12-13 A | 100% |  |  |  | R4 | 4944h | 4944h | NR_n259 | 42 | Ericsson | Rel-16 | 83 |  |  |
| 2309 | 976.7.1 | Core part: Introduction of NR band n259 | 206d | 2019-03-01 A | 2019-12-13 A | 100% |  |  | finish no earlier than 2019-12-15 | R4 | 1648h | 1648h | NR_n259-Core | 42 | Ericsson | Rel-16 | 83 |  |  |
| 2310 | 976.7.2 | Perf. part: Introduction of NR band n259 | 206d | 2019-03-01 A | 2019-12-13 A | 100% |  |  | finish no earlier than 2019-12-15 | R4 | 1648h | 1648h | NR_n259-Perf | 42 | Ericsson | Rel-16 | 83 |  |  |
| 2311 | 976.8 | **Introduction of NR band n26** | 127d | 2019-09-19 A | 2020-03-13 A | 100% |  |  |  | R4 | 3048h | 3048h | NR_n26 | 43 | Sprint | Rel-16 | 85 |  |  |
| 2312 | 976.8.1 | Core part: Introduction of NR band n26 | 127d | 2019-09-19 A | 2020-03-13 A | 100% |  |  | finish no earlier than 2020-03-15 | R4 | 1016h | 1016h | NR_n26-Core | 43 | Sprint | Rel-16 | 85 |  |  |
| 2313 | 976.8.2 | Perf. part: Introduction of NR band n26 | 127d | 2019-09-19 A | 2020-03-13 A | 100% |  |  | finish no earlier than 2020-03-15 | R4 | 1016h | 1016h | NR_n26-Perf | 43 | Sprint | Rel-16 | 85 |  |  |

Notes:
- 2288: 26/6/19: WID:RP-190693->RP-191566; 8/10/19: WID:RP-191566->RP-191824; 14/1/20: WID:RP-191824->RP-192617; 26/3/20: WID:RP-192617->RP-200171; 28/7/20: WID:RP-200171->RP-200673
- 2289: 28/7/20: 0%->100
- 2290: 28/7/20: 0%->100
- 2291: 16/1/19: WID:RP-181445->RP-182258
- 2292: testing all new NR band(s) and NR channel bandwidth addition Wis of REL-16; 14/1/20: WID:RP-192128->RP-192893; 26/3/20: WID:RP-192893->RP-200146; 28/7/20: WID:RP-200146->RP-200633; 8/10/20: 0%->47; 8/10/20: FCD:15/06/2020->12/20; 8/4/21: 47%->67; 8/4/2...; 9/1/23: 100%->100
- 2293: 16/1/19: WID:RP-181445->RP-182258¦26/3/19: WID:RP-182258->RP-190360
- 2294: 26/3/19: WID:RP-182258->RP-190360; 26/6/19: 0%->100
- 2295: 26/3/19: WID:RP-182258->RP-190360; 26/6/19: 0%->100
- 2296: 26/3/19: WID:RP-182826->RP-190173; 26/6/19: WID:RP-190173->RP-191556
- 2297: 26/3/19: WID:RP-182826->RP-190173; 26/6/19: 0%->100
- 2298: 26/3/19: WID:RP-182826->RP-190173; 26/6/19: 0%->100
- 2299: 26/6/19: WID:RP-182865->RP-190908
- 2300: 26/6/19: 0%->100
- 2301: 26/6/19: 0%->100
- 2302: 26/6/19: WID:RP-190165->RP-190965
- 2303: 26/6/19: 0%->100
- 2304: 26/6/19: 0%->100
- 2305: 26/6/19: WID:RP-190166->RP-190967
- 2306: 26/6/19: 0%->100
- 2307: 26/6/19: 0%->100
- 2308: 26/6/19: WID:RP-190765->RP-191416; 8/10/19: WID:RP-191416->RP-191880; 26/3/20: WID:NR_n259->RP-200249
- 2309: 28/7/20: 0%->100
- 2310: 28/7/20: 0%->100
- 2311: UL: 814-849MHz, DL: 859-894MHz; 14/1/20: WID:RP-192273->RP-192736
- 2312: 26/3/20: 0%->100
- 2313: 26/3/20: 0%->100

| ID | WBS | Task | Duration | Start | Finish | Complete | Remaining | Total slack | Constraint | Resources | Work | Actual work | Acronym | PCG approved | WI rapporteur name | Release | TSG approved | WI rapporteur e-mail | Status Report | Impacted TSs and TRs |
| --- | --- | --- | --- | --- | --- | --- | --- | --- | --- | --- | --- | --- | --- | --- | --- | --- | --- | --- | --- | --- |
| 2314 | 976.9 | **Introduction of NR supplementary DL band n29** | 65d | 2019-06-17 A | 2019-09-13 A | 100% |  |  |  | R4 | 1560h | 1560h | NR_n29 | 43 | Dish Network | Rel-16 | 84 |  |  |  |
| 2315 | 976.9.1 | Core part: Introduction of NR supplementary DL band n29 | 65d | 2019-06-17 A | 2019-09-13 A | 100% |  |  | finish no earlier than 2019-09-15 | R4 | 520h | 520h | NR_n29-Core | 43 | Dish Network | Rel-16 | 84 |  |  |  |
| 2316 | 976.9.2 | Perf. part: Introduction of NR supplementary DL band n29 | 65d | 2019-06-17 A | 2019-09-13 A | 100% |  |  | finish no earlier than 2019-09-15 | R4 | 520h | 520h | NR_n29-Perf | 43 | Dish Network | Rel-16 | 84 |  |  |  |
| 2317 | 976.10 | **Introduction of 2010-2025MHz SUL (supplemental uplink) band for NR** | 127d | 2019-09-19 A | 2020-03-13 A | 100% |  |  |  | R4 | 3048h | 3048h | NR_SUL_band_2010_2025MHz | 43 | CMCC | Rel-16 | 85 |  |  |  |
| 2318 | 976.10.1 | Core part: Introduction of 2010-2025MHz SUL (supplemental uplink) band for NR | 127d | 2019-09-19 A | 2020-03-13 A | 100% |  |  | finish no earlier than 2020-03-15 | R4 | 1016h | 1016h | NR_SUL_band_2010_2025MHz-Core | 43 | CMCC | Rel-16 | 85 |  |  |  |
| 2319 | 976.10.2 | Perf. part: Introduction of 2010-2025MHz SUL (supplemental uplink) band for NR | 127d | 2019-09-19 A | 2020-03-13 A | 100% |  |  | finish no earlier than 2020-03-15 | R4 | 1016h | 1016h | NR_SUL_band_2010_2025MHz-Perf | 43 | CMCC | Rel-16 | 85 |  |  |  |
| 2320 | 976.11 | **Introduction of band n53** | 65d | 2019-12-16 A | 2020-03-13 A | 100% |  |  |  | R4 | 1560h | 1560h | NR_n53 | 44 | Globalstar | Rel-16 | 86 |  |  |  |
| 2321 | 976.11.1 | Core part: Introduction of band n53 | 65d | 2019-12-16 A | 2020-03-13 A | 100% |  |  | finish no earlier than 2020-03-15 | R4 | 520h | 520h | NR_n53-Core | 44 | Globalstar | Rel-16 | 86 |  |  |  |
| 2322 | 976.11.2 | Perf. part: Introduction of band n53 | 65d | 2019-12-16 A | 2020-03-13 A | 100% |  |  | finish no earlier than 2020-03-15 | R4 | 520h | 520h | NR_n53-Perf | 44 | Globalstar | Rel-16 | 86 |  |  |  |
| 2323 | 977 | **New Radio Band-related topics** | 1306d | 2018-12-13 A | 2023-12-12 | 99% | 0d | 0d |  | R4 | 98784h | 77376.7h |  | 42 | Dish Network | Rel-16 | 83 |  |  |  |
| 2324 | 977.1 | **RF requirements for NR frequency range 1 (FR1)** | 1250d | 2019-03-01 A | 2023-12-12 | 99% | 0d | 0d |  | R4 | 22480h | 17400.7h | NR_RF_FR1 | 42 | Huawei | Rel-16 | 83 |  |  |  |
| 2325 | 977.1.1 | Core part: RF requirements for NR FR1 | 261d | 2019-03-01 A | 2020-02-28 A | 100% |  |  | finish no earlier than 2020-03-01 | R4 | 2088h | 2088h | NR_RF_FR1-Core | 42 | Huawei | Rel-16 | 83 |  |  |  |
| 2326 | 977.1.2 | Perf. Part: RF requirements for NR FR1 | 327d | 2019-03-01 A | 2020-06-01 A | 100% |  |  | finish no earlier than 2020-06-01 | R4 | 2616h | 2616h | NR_RF_FR1-Perf | 42 | Huawei | Rel-16 | 83 |  |  |  |
| 2327 | 977.1.3 | UE Conformance Test Aspects - RF requirements for NR FR1 | 972d | 2020-03-25 A | 2023-12-12 A | 100% |  |  | finish no earlier than 2023-12-12 | R5 | 7776h | 7776h | NR_RF_FR1-UEConTest | 44 | Yuxin HAO, Huawei Technologies. Co., Ltd. | Rel-16 | 87 | haoyuxin@huawei.com | RP-233756 |  |
| 2328 | 977.2 | **Add support of NR DL 256QAM for frequency range 2 (FR2)** | 792d | 2019-03-01 A | 2022-03-11 A | 100% |  |  |  | R4 | 14240h | 14240h | NR_DL256QAM_FR2 | 42 | China Telecom | Rel-16 | 83 |  |  |  |
| 2329 | 977.2.1 | Core part: Add support of NR DL 256QAM for FR2 | 261d | 2019-03-01 A | 2020-02-28 A | 100% |  |  | finish no earlier than 2020-03-01 | R4 | 2088h | 2088h | NR_DL256QAM_FR2-Core | 42 | China Telecom | Rel-16 | 83 |  |  | 38.883 |
| 2330 | 977.2.2 | Perf. part: Add support of NR DL 256QAM for FR2 | 403d | 2019-03-01 A | 2020-09-15 A | 100% |  |  | finish no earlier than 2020-09-15 | R4 | 3224h | 3224h | NR_DL256QAM_FR2-Perf | 42 | China Telecom | Rel-16 | 83 |  |  |  |
| 2331 | 977.2.3 | UE Conformance Test Aspects - Add support of NR DL 256QAM for FR2 | 325d | 2020-12-14 A | 2022-03-11 A | 100% |  |  | finish no earlier than 2022-06-22 | R5 | 2600h | 2600h | NR_DL256QAM_FR2-UEConTest | 46 | China Telecom | Rel-16 | 90 |  | RP-220571 |  |
| 2332 | 977.3 | **NR RF requirement enhancements for frequency range 2 (FR2)** | 1193d | 2019-03-01 A | 2023-09-22 | 99% | 0d | 0d |  | R4 | 17952h | 10576h | NR_RF_FR2_req_enh | 42 | Nokia | Rel-16 | 83 |  |  |  |
| 2333 | 977.3.1 | Core part: NR RF requirement enhancements for FR2 | 261d | 2019-03-01 A | 2020-02-28 A | 100% |  |  | finish no earlier than 2020-03-01 | R4 | 2088h | 2088h | NR_RF_FR2_req_enh-Core | 42 | Nokia | Rel-16 | 83 |  |  | 38.831 |
| 2334 | 977.3.2 | Perf. part: NR RF requirement enhancements for FR2 | 127d | 2019-09-19 A | 2020-03-13 A | 100% |  |  | finish no earlier than 2020-03-15 | R4 | 1016h | 1016h | NR_RF_FR2_req_enh-Perf | 43 | Nokia | Rel-16 | 85 |  |  |  |
| 2335 | 977.3.3 | UE Conformance Test Aspects - NR RF requirement enhancements for frequency range 2 (FR2) | 663d | 2021-03-12 A | 2023-09-22 A | 100% |  |  | finish no earlier than 2023-09-22 | R5 | 5304h | 5304h | NR_RF_FR2_req_enh-UEConTest | 46 | Tuomo S yn j kangas, Ashwin Mohan, Nokia, Apple | Rel-16 | 91 | tuomo.saynajakangas@nokia.com ashwin_mohan@apple.com | RP-231610 |  |
| 2336 | 977.4 | **Introduction of an NR SUL (supplemental uplink) band with same uplink frequency range as NR band n5** | 141d | 2019-03-01 A | 2019-09-13 A | 100% |  |  |  | R4 | 3384h | 3384h | NR_SUL_UL_n5 | 42 | Huawei | Rel-16 | 83 |  |  |  |
| 2337 | 977.4.1 | Core part: Introduction of an NR SUL band with same uplink frequency range as NR band n5 | 141d | 2019-03-01 A | 2019-09-13 A | 100% |  |  | finish no earlier than 2019-09-15 | R4 | 1128h | 1128h | NR_SUL_UL_n5-Core | 42 | Huawei | Rel-16 | 83 |  |  |  |
| 2338 | 977.4.2 | Perf. part: Introduction of an NR SUL band with same uplink frequency range as NR band n5 | 141d | 2019-03-01 A | 2019-09-13 A | 100% |  |  | finish no earlier than 2019-09-15 | R4 | 1128h | 1128h | NR_SUL_UL_n5-Perf | 42 | Huawei | Rel-16 | 83 |  |  |  |

Notes:
- 2314: 8/10/19: WID:RP-191474->RP-192236
- 2315: 8/10/19: 0%->100
- 2316: 8/10/19: 0%->100
- 2317: 14/1/20: WID:RP-192274->RP-192584
- 2318: 14/1/20: 0%->100
- 2319: 14/1/20: 0%->100
- 2320: affects: NR.
- 2321: affects: NR.; 18/2/20: FCD:15/06/2020->03/20. Rel17->Rel-16; 26/3/20: 0%->100
- 2322: affects: NR.; 18/2/20: FCD:15/06/2020->03/20. Rel17->Rel-16; 26/3/20: 0%->100
- 2323: 16/1/19: WID:RP-181445->RP-182258
- 2324: 26/6/19: WID:RP-190759->RP-191114; 8/10/19: WID:RP-191114->RP-192282; 14/1/20: WID:RP-192282->RP-193266
- 2325: 25/9/20: 0%->100
- 2326: 6/1/21: 0%->100
- 2327: affects: NR. TR 38.8xx; 8/10/20: 0%->15; 8/4/21: 15%->43; ; 6/6/22: CD:10/06/2022->22/12/2022 ; 20/6/22: Rapporteur: Huawei->Chunying Gu, Huawei Technologies. Co., Ltd.; Rap eMail: ->guchunying@huawei.com9/9/22: Compl:64%->69%; 9/12/22: FCD:22/12/20...; 8/12/23: Compl:73%->100%; Stat Rep: RP-232347->RP-233756;
- 2328: 26/6/19: WID:RP-190760->RP-190925; 8/10/19: WID:RP-190925->RP-191891; 26/3/20: WID:RP-191891->RP-200124
- 2329: 8/10/19: 38.883 added;; 28/7/20: 0%->100
- 2330: 7/4/21: 0%->100
- 2331: tested: REL-16 WI NR_DL256QAM_FR2-Core ; 8/4/21: 0%->20; 2/7/21: 20%->44; 13/9/21: Compl:44%->82%; 13/9/21: CD:Fri 10/06/22->Wed 22/06/22 ; ;
- 2332: 26/6/19: WID:RP-190761->RP-191290; 8/10/19: WID:RP-191290->RP-192227; 14/1/20: WID:RP-192227->RP-192653; 26/3/20: WID:RP-192653->RP-200246; 28/7/20: WID:RP-200246->RP-200668; 25/9/20: WID:RP-200668->RP-201606
- 2333: 8/10/19: 38.831 added;; 25/9/20: 0%->100
- 2334: 25/9/20: 0%->100
- 2335: tested: REL-16 WI NR_RF_FR2_req_enh-Core ; 2/7/21: 0%->20; 29/9/21: WID:RP-210363->RP-212304; 22/3/22: Compl:20%->57% ; 20/6/22: Rapporteur: Nokia->Tuomo S yn j kangas, Ashwin Mohan, Nokia, Apple; Rap eMail: ->tuomo.saynajakangas@nokia.com ashwin...;...; 6/9/23: FCD:09/09/2023->22/09/2023; Compl:98%->100%; Stat Rep: RP-230128->RP-231610;
- 2336: 26/6/19: WID:RP-190390->RP-191116; 8/10/19: WID:RP-191116->RP-192080
- 2337: 8/10/19: 0%->100
- 2338: 8/10/19: 0%->100

| ID | WBS | Task | Duration | Start | Finish | Complete | Constraint | Resources | Work | Actual work | Acronym | PCG approved | WI rapporteur name | Release | TSG approved | TSG stopped |
| --- | --- | --- | --- | --- | --- | --- | --- | --- | --- | --- | --- | --- | --- | --- | --- | --- |
| 2339 | 977.5 | **Adding wider channel bandwidths in NR band n7** | 197d | 2018-12-13 A | 2019-09-13 A | 100% |  | R4 | 3152h | 3152h | NR_n7_BW | 42 | BT | Rel-16 | 82 |  |
| 2340 | 977.5.1 | Core part: Adding wider channel bandwidths in NR band n7 | 197d | 2018-12-13 A | 2019-09-13 A | 100% | start no earlier than 2018-12-13 | R4 | 1576h | 1576h | NR_n7_BW-Core | 42 | BT | Rel-16 | 82 |  |
| 2341 | 977.6 | **Addition of wider channel bandwidth in NR band n38** | 206d | 2019-03-01 A | 2019-12-13 A | 100% |  | R4 | 4944h | 4944h | NR_n38_BW | 42 | Huawei | Rel-16 | 83 |  |
| 2342 | 977.6.1 | Core part: Addition of wider channel bandwidth in NR band n38 | 206d | 2019-03-01 A | 2019-12-13 A | 100% | finish no earlier than 2019-12-15 | R4 | 1648h | 1648h | NR_n38_BW-Core | 42 | Huawei | Rel-16 | 83 |  |
| 2343 | 977.6.2 | Perf. part: Addition of wider channel bandwidth in NR band n38 | 206d | 2019-03-01 A | 2019-12-13 A | 100% | finish no earlier than 2019-12-15 | R4 | 1648h | 1648h | NR_n38_BW-Perf | 42 | Huawei | Rel-16 | 83 |  |
| 2344 | 977.7 | **Addition of further channel bandwidths in NR band 38** | 127d | 2019-09-19 A | 2020-03-13 A | 100% |  | R4 | 3048h | 3048h | NR_n38_BW2 | 43 | Ericsson | Rel-16 | 85 |  |
| 2345 | 977.7.1 | Core part: Addition of further channel bandwidths in NR band 38 | 127d | 2019-09-19 A | 2020-03-13 A | 100% | finish no earlier than 2020-03-15 | R4 | 1016h | 1016h | NR_n38_BW2-Core | 43 | Ericsson | Rel-16 | 85 |  |
| 2346 | 977.7.2 | Perf. part: Addition of further channel bandwidths in NR band 38 | 127d | 2019-09-19 A | 2020-03-13 A | 100% | finish no earlier than 2020-03-15 | R4 | 1016h | 1016h | NR_n38_BW2-Perf | 43 | Ericsson | Rel-16 | 85 |  |
| 2347 | 977.8 | **Addition of 30MHz channel bandwidth for NR band n41** | 134d | 2018-12-13 A | 2019-06-18 A | 100% |  | R4 | 3216h | 3216h | NR_n41_BW | 42 | KDDI | Rel-16 | 82 |  |
| 2348 | 977.8.1 | Core part: Addition of 30MHz channel bandwidth for NR band n41 | 134d | 2018-12-13 A | 2019-06-18 A | 100% | start no earlier than 2018-12-13 | R4 | 1072h | 1072h | NR_n41_BW-Core | 42 | KDDI | Rel-16 | 82 |  |
| 2349 | 977.8.2 | Stopped - Perf. part: Addition of 30MHz channel bandwidth for NR band n41 | 134d | 2018-12-13 A | 2019-06-18 A | 100% | start no earlier than 2018-12-13 | R4 | 1072h | 1072h | NR_n41_BW-Perf | 42 | KDDI | Rel-16 | 82 | 84 |
| 2350 | 977.9 | **Adding wider channel bandwidths in NR band n50** | 134d | 2018-12-13 A | 2019-06-18 A | 100% |  | R4 | 2144h | 2144h | NR_n50_BW | 42 | Huawei | Rel-16 | 82 |  |
| 2351 | 977.9.1 | Core part: Adding wider channel bandwidths in NR band n50 | 134d | 2018-12-13 A | 2019-06-18 A | 100% | start no earlier than 2018-12-13 | R4 | 1072h | 1072h | NR_n50_BW-Core | 42 | Huawei | Rel-16 | 82 |  |
| 2352 | 977.10 | **Addition of wider channel bandwidths in NR band n75** | 127d | 2019-09-19 A | 2020-03-13 A | 100% |  | R4 | 3048h | 3048h | NR_n75_BW | 43 | Ericsson | Rel-16 | 85 |  |
| 2353 | 977.10.1 | Core part: Addition of wider channel bandwidths in NR band n75 | 127d | 2019-09-19 A | 2020-03-13 A | 100% | finish no earlier than 2020-03-15 | R4 | 1016h | 1016h | NR_n75_BW-Core | 43 | Ericsson | Rel-16 | 85 |  |
| 2354 | 977.10.2 | Perf. part: Addition of wider channel bandwidths in NR band n75 | 127d | 2019-09-19 A | 2020-03-13 A | 100% | finish no earlier than 2020-03-15 | R4 | 1016h | 1016h | NR_n75_BW-Perf | 43 | Ericsson | Rel-16 | 85 |  |
| 2355 | 977.11 | **Addition of 25, 30, 35 and 40 MHz channel bandwidth for NR band n25** | 127d | 2019-09-19 A | 2020-03-13 A | 100% |  | R4 | 3048h | 3048h | NR_n25_BW | 43 | Nokia | Rel-16 | 85 |  |
| 2356 | 977.11.1 | Core part: Addition of 25, 30, 35 and 40 MHz channel bandwidth for NR band n25 | 127d | 2019-09-19 A | 2020-03-13 A | 100% | finish no earlier than 2020-03-15 | R4 | 1016h | 1016h | NR_n25_BW-Core | 43 | Nokia | Rel-16 | 85 |  |
| 2357 | 977.11.2 | Perf. part: Addition of 25, 30, 35 and 40 MHz channel bandwidth for NR band n25 | 127d | 2019-09-19 A | 2020-03-13 A | 100% | finish no earlier than 2020-03-15 | R4 | 1016h | 1016h | NR_n25_BW-Perf | 43 | Nokia | Rel-16 | 85 |  |
| 2358 | 977.12 | **Addition of wider channel bandwidths in NR band n28** | 127d | 2019-09-19 A | 2020-03-13 A | 100% |  | R4 | 3048h | 3048h | NR_n28_BW | 43 | CBN | Rel-16 | 85 |  |
| 2359 | 977.12.1 | Core part: Addition of wider channel bandwidths in NR band n28 | 127d | 2019-09-19 A | 2020-03-13 A | 100% | finish no earlier than 2020-03-15 | R4 | 1016h | 1016h | NR_n28_BW-Core | 43 | CBN | Rel-16 | 85 |  |
| 2360 | 977.12.2 | Perf. part: Addition of wider channel bandwidths in NR band n28 | 127d | 2019-09-19 A | 2020-03-13 A | 100% | finish no earlier than 2020-03-15 | R4 | 1016h | 1016h | NR_n28_BW-Perf | 43 | CBN | Rel-16 | 85 |  |
| 2361 | 977.13 | **Addition of new channel bandwidth in NR band n1** | 127d | 2019-09-19 A | 2020-03-13 A | 100% |  | R4 | 3048h | 3048h | NR_n1_BW2 | 43 | China Unicom | Rel-16 | 85 |  |
| 2362 | 977.13.1 | Core part: Addition of new channel bandwidth in NR band n1 | 127d | 2019-09-19 A | 2020-03-13 A | 100% | finish no earlier than 2020-03-15 | R4 | 1016h | 1016h | NR_n1_BW2-Core | 43 | China Unicom | Rel-16 | 85 |  |
| 2363 | 977.13.2 | Perf. part: Addition of new channel bandwidth in NR band n1 | 127d | 2019-09-19 A | 2020-03-13 A | 100% | finish no earlier than 2020-03-15 | R4 | 1016h | 1016h | NR_n1_BW2-Perf | 43 | China Unicom | Rel-16 | 85 |  |

Notes:
- 2339: no Perf. part¦26/3/19: WID:RP-182827->RP-190137
- 2340: no Perf. part¦26/3/19: WID:RP-182827->RP-190137; 8/10/19: 0%->100
- 2341: 26/6/19: WID:RP-190392->RP-191472; 14/1/20: WID:RP-191472->RP-192513; 13/6/21: WID:RP-192513->RP-191472
- 2342: 14/1/20: 0%->100
- 2343: 14/1/20: 0%->100
- 2344: 13/6/21: WID:RP-192215->RP-192513
- 2345: compare REL-16 WI NR_n38_BW; 26/3/20: 0%->100
- 2346: 26/3/20: 0%->100
- 2347: 26/3/19: WID:RP-182828->RP-190174; 26/6/19: WID:RP-190174->RP-191569; 8/10/19: WID:RP-191569->RP-191681
- 2348: 26/3/19: WID:RP-182828->RP-190174; 8/10/19: 0%->100
- 2349: 26/3/19: WID:RP-182828->RP-190174. 08/10/2019: stopped at 0%; 8/10/19: 0%->100
- 2350: no Perf. part
- 2351: no Perf. part; 26/6/19: 0%->100
- 2353: 14/1/20: 0%->100
- 2354: 14/1/20: 0%->100
- 2355: 14/1/20: WID:RP-192219->RP-192401
- 2356: 14/1/20: 0%->100
- 2357: 14/1/20: 0%->100
- 2358: 14/1/20: WID:RP-192261->RP-192656
- 2359: 26/3/20: 0%->100
- 2360: 26/3/20: 0%->100
- 2361: 8/10/19: WID:RP-192275->RP-192009. compare REL-16 WI NR_n1_BW; 14/1/20: WID:RP-192275->RP-192801
- 2362: 28/7/20: 0%->100
- 2363: 28/7/20: 0%->100

| ID | WBS | Task | Type | Duration | Start | Finish | Complete | Actual finish | Constraint | Resources | Work | Actual work | Acronym | PCG approved | Release | TSG approved | WI rapporteur e-mail | Status Report | Impacted TSs and TRs |
| --- | --- | --- | --- | --- | --- | --- | --- | --- | --- | --- | --- | --- | --- | --- | --- | --- | --- | --- | --- |
| 2364 | 977.14 | **Addition of asymmetric channel bandwidth for NR band n66** |  | 127d | 2019-09-19 A | 2020-03-13 A | 100% |  |  | R4 | 2032h | 2032h | NR_n66_BW | 43 | Rel-16 | 85 |  |  |  |
| 2365 | 977.14.1 | Core part: Addition of asymmetric channel bandwidth for NR band n66 |  | 127d | 2019-09-19 A | 2020-03-13 A | 100% |  | finish no earlier than 2020-03-15 | R4 | 1016h | 1016h | NR_n66_BW-Core | 43 | Rel-16 | 85 |  |  |  |
| 2366 | 978 | **Enhancements on MIMO for NR** |  | 1116d? | 2018-06-15 A | 2022-09-22 A | 100% |  |  | R1 | 21464h | 21464h | NR_eMIMO | 41 | Rel-16 | 80 |  |  |  |
| 2367 | 978.1 | Core part: Enhancements on MIMO for NR |  | 391d? | 2018-06-15 A | 2019-12-13 A | 100% |  | finish no earlier than 2019-12-15 | R1 | 3128h | 3128h | NR_eMIMO-Core | 41 | Rel-16 | 80 |  |  |  |
| 2368 | 978.2 | Perf. part: Enhancements on MIMO for NR |  | 588d? | 2018-06-15 A | 2020-09-15 A | 100% |  | finish no earlier than 2020-09-15 | R4 | 4704h | 4704h | NR_eMIMO-Perf | 41 | Rel-16 | 80 |  |  |  |
| 2369 | 978.3 | UE Conformance Test Aspects - Enhancements on MIMO for NR |  | 589d | 2020-06-22 A | 2022-09-22 A | 100% |  | finish no earlier than 2022-12-22 | R5 | 4712h | 4712h | NR_eMIMO-UEConTest | 45 | Rel-16 | 88 | guchunying@huawei.com | RP-221483 |  |
| 2370 | 979 | **NR mobility enhancements** |  | 1116d? | 2018-06-15 A | 2022-09-22 A | 100% |  |  | R2 | 19888h | 19888h | NR_Mob_enh | 41 | Rel-16 | 80 |  |  |  |
| 2371 | 979.1 | Core part: NR mobility enhancements |  | 391d? | 2018-06-15 A | 2019-12-13 A | 100% |  | finish no earlier than 2019-12-15 | R2 | 3128h | 3128h | NR_Mob_enh-Core | 41 | Rel-16 | 80 |  |  |  |
| 2372 | 979.2 | Perf. part: NR mobility enhancements |  | 391d? | 2018-06-15 A | 2019-12-13 A | 100% |  | finish no earlier than 2019-12-15 | R4 | 3128h | 3128h | NR_Mob_enh-Perf | 41 | Rel-16 | 80 |  |  |  |
| 2373 | 979.3 | UE Conformance Test Aspects - NR Mobility Enhancements |  | 589d | 2020-06-22 A | 2022-09-22 A | 100% |  | finish no earlier than 2022-12-22 | R5 | 4712h | 4712h | NR_Mob_enh-UEConTest | 45 | Rel-16 | 88 | yangzhaobing @hisilicon.com | RP-221480 |  |
| 2374 | 980 | **2-step RACH for NR** |  | 262d | 2018-12-15 A | 2019-12-15 | 100% | 2022-09-22 |  | R1 | 8472h | 8472h | NR_2step_RACH | 42 | Rel-16 | 82 |  |  |  |
| 2375 | 980.1 | Core part: 2-step RACH for NR | manual | 262d | 2018-12-15 A | 2019-12-15 A | 100% |  |  | R1 | 2096h | 2096h | NR_2step_RACH-Core | 42 | Rel-16 | 82 |  |  |  |
| 2376 | 980.2 | Perf. part: 2-step RACH for NR | manual | 135d | 2018-12-15 A | 2019-06-20 A | 100% |  |  | R4 | 1080h | 1080h | NR_2step_RACH-Perf | 42 | Rel-16 | 82 |  |  |  |
| 2377 | 980.3 | UE Conformance Test Aspects - 2-step RACH for NR |  | 400d | 2021-03-12 A | 2022-09-22 A | 100% |  | finish no earlier than 2022-12-22 | R5 | 3200h | 3200h | NR_2step_RACH-UEConTest | 46 | Rel-16 | 91 | ma.wei4@zte.com.cn, zhaoj16@chinatelecom.cn | RP-221195 |  |
| 2378 | 981 | **SON (Self-Organising Networks) and MDT (Minimization of Drive Tests) support for NR** |  | 789d | 2019-06-17 A | 2022-06-22 A | 100% |  |  | R3 | 11544h | 11544h | NR_SON_MDT | 43 | Rel-16 | 84 |  |  |  |
| 2379 | 981.1 | Core part: SON (Self-Organising Networks) and MDT (Minimization of Drive Tests) support for NR |  | 195d | 2019-06-17 A | 2020-03-13 A | 100% |  | finish no earlier than 2020-03-15 | R3 | 1560h | 1560h | NR_SON_MDT-Core | 43 | Rel-16 | 84 |  |  | 38.314 |
| 2380 | 981.2 | UE Conformance Test Aspects - SON (Self-Organising Networks) and MDT (Minimization of Drive Tests) support for NR |  | 460d | 2020-09-17 A | 2022-06-22 A | 100% |  | finish no earlier than 2022-06-22 | R5 | 3680h | 3680h | NR_SON_MDT-UEConTest | 45 | Rel-16 | 89 | dongwenjia@chinamobile.com, leif.mattisson@ericsson.com | RP-221368 |  |
| 2381 | 982 | Study on Self-Organizing Networks (SON) for 5G |  | 202d? | 2018-09-06 A | 2019-06-14 A | 100% |  | finish no earlier than 2019-06-14 | S5 | 1616h | 1616h | FS_SON_5G | 41 | Rel-16 | 81 | joey<dot>chou<at>intel<dot>com |  | New |
| 2382 | 983 | Self-Organizing Networks (SON) for 5G networks |  | 258d | 2019-09-19 A | 2020-09-14 A | 100% |  | finish no earlier than 2020-09-14 | S5 | 2064h | 2064h | SON_5G | 43 | Rel-16 | 85 | joey<dot>chou<at>intel<dot>com |  | 28.552; 28.545 ; 28.544; 28.313 |
| 2383 | 984 | **RRM requirement for CSI-RS based L3 measurement in NR** |  | 327d | 2019-06-17 A | 2020-09-15 A | 100% |  |  | R4 | 6792h | 6792h | NR_CSIRS_L3meas | 43 | Rel-16 | 84 |  |  |  |
| 2384 | 984.1 | Core part: RRM requirement for CSI-RS based L3 measurement in NR |  | 195d | 2019-06-17 A | 2020-03-13 A | 100% |  | finish no earlier than 2020-03-15 | R4 | 1560h | 1560h | NR_CSIRS_L3meas-Core | 43 | Rel-16 | 84 |  |  |  |
| 2385 | 984.2 | Perf. part: RRM requirement for CSI-RS based L3 measurement in NR |  | 327d | 2019-06-17 A | 2020-09-15 A | 100% |  | finish no earlier than 2020-09-15 | R4 | 2616h | 2616h | NR_CSIRS_L3meas-Perf | 43 | Rel-16 | 84 |  |  |  |
| 2386 | 985 | **NR performance requirement enhancement** |  | 789d | 2019-06-17 A | 2022-06-22 A | 100% |  |  | R4 | 10504h | 10504h | NR_perf_enh | 43 | Rel-16 | 84 |  |  |  |
| 2387 | 985.1 | Perf. part: NR performance requirement enhancement |  | 65d | 2019-06-17 A | 2019-09-13 A | 100% |  | finish no earlier than 2019-09-15 | R4 | 520h | 520h | NR_perf_enh-Perf | 43 | Rel-16 | 84 |  |  |  |
| 2388 | 985.2 | UE Conformance Test Aspects - NR performance requirement enhancement |  | 460d | 2020-09-17 A | 2022-06-22 A | 100% |  | finish no earlier than 2022-06-22 | R5 | 3680h | 3680h | NR_perf_enh-UEConTest | 45 | Rel-16 | 89 | wujingzhou@chinatelecom.cn, vijayb@qti.qualcomm.com | RP-221294 |  |

Notes:
- 2364: no Perf. Part; 14/1/20: WID:RP-192276->RP-192808; 26/3/20: WID:RP-192808->RP-200265 / WI rapporteur name: Huawei
- 2365: 28/7/20: WID:RP-200265->RP-201010; 28/7/20: 0%->100 / WI rapporteur name: Huawei
- 2366: 16/1/19: WID:RP-181453->RP-182863; 8/10/19: WID:RP-182863->RP-192271; 26/3/20: WID:RP-192271->RP-200474 / WI rapporteur name: Samsung
- 2367: 25/9/20: 0%->100 / WI rapporteur name: Samsung
- 2368: 7/4/21: 0%->100 / WI rapporteur name: Samsung
- 2369: 8/10/20: 0%->1; 8/4/21: 1%->16; 2/7/21: 16%->20; 22/3/22: Compl:20%->57%; 6/6/22: Compl:57%-> ; 20/6/22: Rapporteur: Huawei->Chunying GU, Huawei; Rap eMail: ->guchunying@huawei.com 9/9/22: Compl:64%->100% ; 9/9/22: CD:22/12/202... / WI rapporteur name: Chunying GU, Huawei
- 2370: 26/3/19: WID:RP-181433->RP-190489; 8/10/19: WID:RP-190489->RP-192277; 14/1/20: WID:RP-192277->RP-192534 / WI rapporteur name: Intel
- 2371: 26/3/19: WID:RP-181433->RP-190489; 28/7/20: 0%->100 / WI rapporteur name: Intel
- 2372: 26/3/19: WID:RP-181433->RP-190489; 6/1/21: 0%->100 / WI rapporteur name: Intel
- 2373: 8/10/20: 0%->5; 8/4/21: 5%->35; 22 6/6/22: CD:10 ; 20/6/22: Rapporteur: Huawei->Zhaobing Yang, Huawei Technologies. Co., Ltd.; Rap eMail: ->yangzhaobing @hisilicon.com12/7/22: WID:RP-200893->RP-2214819/9/22: Compl:97%->100%9/9/22: ... / WI rapporteur name: Zhaobing Yang, Huawei Technologies. Co., Ltd.
- 2374: WI was created after REL-16 SI FS_NR_NOMA was completed¦26/3/19: WID:RP-182894->RP-190711; 8/10/19: WID:RP-190711->RP-192330; 26/3/20: WID:RP-192330->RP-200085 / WI rapporteur name: ZTE
- 2375: WI was created after REL-16 SI FS_NR_NOMA was completed¦26/3/19: WID:RP-182894->RP-190711; 28/7/20: 0%->100; 28/7/20: 100%->100 / WI rapporteur name: ZTE
- 2376: 26/3/19: WID:RP-182894->RP-190711; 6/1/21: 0%->100 / WI rapporteur name: ZTE
- 2377: tested REL-16 WI NR_2step_RACH-Core ; 2/7/21: 0%->25; 13/9/21: Compl:25%->54%; 13/9/21: CD:Fri 11/03/22->Tue 22/03/22; 13/9/21: Stat Rep: ->RP-211763; 20/6/22: Rapporteur: ZTE->Wei Ma, Jing Zhao, ZTE, China Telecom; Rap eMail: ->ma.wei4@zte.com... / WI rapporteur name: Wei Ma, Jing Zhao, ZTE, China Telecom
- 2378: no Perf. part; impact on SA2, SA5, CT4?; TR 38.314 / WI rapporteur name: CMCC
- 2379: no Perf. part; impact on SA2, SA5, CT4?; TR 38.314; 8/10/19: WID:RP-191594->RP-191776; 8/10/19: 38.314 added;; 14/1/20: WID:RP-191776->RP-192610; 28/7/20: 0%->100 / WI rapporteur name: CMCC
- 2380: tested: REL-16 WI NR_SON_MDT-Core ; 7/4/21: WID:RP-201625->RP-210377; 8/4/21: 0%->37; 2/7/21: 37%->71; 13/9/21: Compl:71%->85%; ; 20/6/22: Rapporteur: CMCC->Wenjia DONG, Leif Mattisson, CMCC, Ericsson; Rap eMail: ->dongwenjia@chinamobile.com, ... / WI rapporteur name: Wenjia DONG, Leif Mattisson, CMCC, Ericsson
- 2381: 7/12/18: 0%->10¦14/3/19: 10%->40; 31/5/19: 40%->50; 6/12/19: 50%->100 / WI rapporteur name: Joey Chou, Intel
- 2382: ; 13/9/19: 0%->80; 8/10/19: 28.544 added;; 8/10/19: 28.313 added;; 28/6/20: 80%->75; 13/9/20: 75%->100; 13/9/20: WID:SP-190785->SP-200763; 13/9/20: FCD:12/03/2020->09/20 / WI rapporteur name: Joey Chou, Intel
- 2383: 8/10/19: WID:RP-191580->RP-191992; 26/3/20: WID:RP-191992->RP-200240; 28/7/20: WID:RP-200240->RP-201345; 25/9/20: WID:RP-201345->RP-201975; 6/1/21: WID:RP-201975->RP-202723; 7/4/21: WID:RP-202723->RP-210590 / WI rapporteur name: CATT
- 2384: 25/9/20: 0%->100 / WI rapporteur name: CATT
- 2385: 2/7/21: 0%->100 / WI rapporteur name: CATT
- 2386: no Core part; 8/10/19: WID:RP-191587->RP-192281; 14/1/20: WID:RP-192281->RP-192532; 26/3/20: WID:RP-192532->RP-200472 / WI rapporteur name: China Telecom
- 2387: no Core part; 7/4/21: 0%->100 / WI rapporteur name: China Telecom
- 2388: tested: REL-16 WI NR_perf_enh-Perf ; 6/1/21: WID:RP-201941->RP-202557; Qualcomm -> China Telecom; 8/4/21: 0%->15; 2/7/21: 15%->18; 13/9/21: Compl:18%->21%; ; 20/6/22: Rapporteur: Qualcomm -> China Telecom->Wu Jingzhou, Balasubramanian Vijay, C... / WI rapporteur name: Wu Jingzhou, Balasubramanian Vijay, China Telecom, Qualcomm Inc

| ID | WBS | Task | Type | Duration | Start | Finish | Complete | Remaining | Total slack | Constraint | Resources | Work | Actual work | Acronym | PCG approved | WI rapporteur name | Release | TSG approved | WI rapporteur e-mail | Status Report |
| --- | --- | --- | --- | --- | --- | --- | --- | --- | --- | --- | --- | --- | --- | --- | --- | --- | --- | --- | --- | --- |
| 2389 | 986 | **NR RRM enhancement** |  | 1302d | 2019-06-17 A | 2024-06-05 | 73% | 346.53d | 454d |  | R4 | 17120h | 5736h | NR_RRM_enh | 43 | Intel | Rel-16 | 84 |  |  |
| 2390 | 986.1 | Core part: NR RRM enhancement |  | 195d | 2019-06-17 A | 2020-03-13 A | 100% |  |  | finish no earlier than 2020-03-15 | R4 | 1560h | 1560h | NR_RRM_enh-Core | 43 | Intel | Rel-16 | 84 |  |  |
| 2391 | 986.2 | Perf. part: NR RRM enhancement |  | 261d | 2019-06-17 A | 2020-06-15 A | 100% |  |  | finish no earlier than 2020-06-15 | R4 | 2088h | 2088h | NR_RRM_enh-Perf | 43 | Intel | Rel-16 | 84 |  |  |
| 2392 | 986.3 | UE Conformance Test Aspects - NR RRM enhancements |  | 519d | 2022-06-15 A | 2024-06-05 | 50% | 259.5d | 454d | finish no earlier than 2024-06-06 | R5 | 4152h |  | NR_RRM_enh-UEConTest | 49 | Xinrong Wang, Apple | Rel-16 | 96 | xinrong_wang@apple.com | RP-233867 |
| 2393 | 987 | **Rel-16 NR inter-band Carrier Aggregation for 4 bands DL with 1 band UL** |  | 195d | 2019-06-17 A | 2020-03-13 A | 100% |  |  |  | R4 | 4680h | 4680h | NR_CA_R16_4BDL_1BUL | 43 | Ericsson | Rel-16 | 84 |  |  |
| 2394 | 987.1 | Core part: Rel-16 NR inter-band Carrier Aggregation for 4 bands DL with 1 band UL |  | 195d | 2019-06-17 A | 2020-03-13 A | 100% |  |  | finish no earlier than 2020-03-15 | R4 | 1560h | 1560h | NR_CA_R16_4BDL_1BUL-Core | 43 | Ericsson | Rel-16 | 84 |  |  |
| 2395 | 987.2 | Perf. part: Rel-16 NR inter-band Carrier Aggregation for 4 bands DL with 1 band UL |  | 195d | 2019-06-17 A | 2020-03-13 A | 100% |  |  | finish no earlier than 2020-03-15 | R4 | 1560h | 1560h | NR_CA_R16_4BDL_1BUL-Perf | 43 | Ericsson | Rel-16 | 84 |  |  |
| 2396 | 988 | **Addition of wider channel bandwidth in NR band n1** |  | 195d | 2019-06-17 A | 2020-03-13 A | 100% |  |  |  | R4 | 4680h | 4680h | NR_n1_BW | 43 | Ericsson | Rel-16 | 84 |  |  |
| 2397 | 988.1 | Core part: Addition of wider channel bandwidth in NR band n1 |  | 195d | 2019-06-17 A | 2020-03-13 A | 100% |  |  | finish no earlier than 2020-03-15 | R4 | 1560h | 1560h | NR_n1_BW-Core | 43 | Ericsson | Rel-16 | 84 |  |  |
| 2398 | 988.2 | Perf. part: Addition of wider channel bandwidth in NR band n1 |  | 195d | 2019-06-17 A | 2020-03-13 A | 100% |  |  | finish no earlier than 2020-03-15 | R4 | 1560h | 1560h | NR_n1_BW-Perf | 43 | Ericsson | Rel-16 | 84 |  |  |
| 2399 | 989 | **Addition of channel bandwidths in Band n77 and n78** |  | 130d | 2019-06-17 A | 2019-12-13 A | 100% |  |  |  | R4 | 2080h | 2080h | NR_n77_n78_BW | 43 | Huawei | Rel-16 | 84 |  |  |
| 2400 | 989.1 | Core part: Addition of channel bandwidths in Band n77 and n78 |  | 130d | 2019-06-17 A | 2019-12-13 A | 100% |  |  | finish no earlier than 2019-12-15 | R4 | 1040h | 1040h | NR_n77_n78_BW-Core | 43 | Huawei | Rel-16 | 84 |  |  |
| 2401 | 990 | **Dual Connectivity (EN-DC) with 3 bands DL and 3 bands UL** |  | 195d | 2019-06-17 A | 2020-03-13 A | 100% |  |  |  | R4 | 4680h | 4680h | DC_R16_LTE_NR_3DL3UL | 43 | ZTE | Rel-16 | 84 |  |  |
| 2402 | 990.1 | Core part: Dual Connectivity (EN-DC) with 3 bands DL and 3 bands UL |  | 195d | 2019-06-17 A | 2020-03-13 A | 100% |  |  | finish no earlier than 2020-03-15 | R4 | 1560h | 1560h | DC_R16_LTE_NR_3DL3UL-Core | 43 | ZTE | Rel-16 | 84 |  |  |
| 2403 | 990.2 | Perf. part: Dual Connectivity (EN-DC) with 3 bands DL and 3 bands UL |  | 195d | 2019-06-17 A | 2020-03-13 A | 100% |  |  | finish no earlier than 2020-03-15 | R4 | 1560h | 1560h | DC_R16_LTE_NR_3DL3UL-Perf | 43 | ZTE | Rel-16 | 84 |  |  |
| 2404 | 991 | **Introduction of NR FDD bands with variable duplex and corresponding framework** |  | 130d | 2019-06-17 A | 2019-12-13 A | 100% |  |  |  | R4 | 2576h | 2576h | NR_FDD_bands_varduplex | 43 | Huawei | Rel-16 | 84 |  |  |
| 2405 | 991.1 | Core part: Introduction of NR FDD bands with variable duplex and corresponding framework |  | 130d | 2019-06-17 A | 2019-12-13 A | 100% |  |  | start no earlier than 2019-06-17 | R4 | 1040h | 1040h | NR_FDD_bands_varduplex-Core | 43 | Huawei | Rel-16 | 84 |  |  |
| 2406 | 991.2 | Perf. part: Introduction of NR FDD bands with variable duplex and corresponding framework |  | 62d | 2019-09-19 A | 2019-12-13 A | 100% |  |  | finish no earlier than 2019-12-15 | R4 | 496h | 496h | NR_FDD_bands_varduplex-Perf | 43 | Huawei | Rel-16 | 85 |  |  |
| 2407 | 992 | **Common RF requirement configured output power for EN-DC with 3 uplink CC and 2 different bands (2CC LTE, 1CC NR FR1)** |  | 757d | 2019-07-31 A | 2022-06-22 | 46% | 408.78d | 967d |  | R4 | 8448h | 3768.11h | DC_Pcmax_3UL_CC | 43 | Huawei | Rel-16 | 84 |  |  |
| 2408 | 992.1 | Core part: Common RF requirement configured output power for EN-DC with 3 uplink CC and 2 different bands (2CC LTE, 1CC NR FR1) |  | 162d | 2019-07-31 | 2020-03-12 |  |  | 1562d | finish no earlier than 2020-03-12 | R4 | 1296h |  | DC_Pcmax_3UL_CC-Core | 43 | Huawei | Rel-16 | 84 |  |  |
| 2409 | 992.2 | UE Conformance Test Aspects - Common RF requirement configured output power for EN-DC with 3 uplink CC and 2 different bands (2CC LTE, 1CC NR FR1) |  | 138d | 2021-12-13 A | 2022-06-22 A | 100% |  |  | finish no earlier than 2022-06-22 | R5 | 1104h | 1104h | DC_Pcmax_3UL_CC-UEConTest | 48 | Huawei | Rel-16 | 94 |  | RP-221486 |
| 2410 | 993 | **Addition of NR UE measurements to enable OTA conformance testing** |  | 27d | 2020-06-22 A | 2020-07-28 A | 100% |  |  |  | R1 | 432h | 432h | NR_OTA_Uemeas | 45 | Keysight Technologies | Rel-16 | 88 |  |  |
| 2411 | 993.1 | Core part: Addition of NR UE measurements to enable OTA conformance testing |  | 27d | 2020-06-22 A | 2020-07-28 A | 100% |  |  | finish no earlier than 2020-07-28 | R1 | 216h | 216h | NR_OTA_Uemeas-Core | 45 | Keysight Technologies | Rel-16 | 88 |  |  |
| 2412 | 994 | Release 16 Features impacting both LTE and NR | milestone | 0d? | 2019-03-07 A | 2019-03-07 A | 100% |  |  |  |  |  |  |  |  |  | Rel-16 |  |  |  |

Notes:
- 2389: 8/10/19: WID:RP-191601->RP-192157; 14/1/20: WID:RP-192157->RP-193211; 26/3/20: WID:RP-193211->RP-200256; 28/7/20: WID:RP-200256->RP-201112; 25/9/20: WID:RP-201112->RP-201883
- 2390: 25/9/20: 0%->100
- 2391: 6/1/21: WID:RP-201883->RP-202655; 7/4/21: 0%->100
- 2392: 9/9/22: Comp...; 9/12/22: FCD:23/12/2022->01/12/2023; Compl:5%->9%; Stat Rep: ->RP-222901; Rapporteur: Apple->Ashwin Mohan, Apple; Rap eMail: ->ashwin_mohan[at]apple.com; 17/3/23: FCD:30/11/2023->12/12/2023; Compl:9%->12%; Stat Rep: RP-22.....; 2/1/24: WID:RP-221705->RP-233858
- 2393: basket WI; TR 38.716-04-01; 8/10/19: WID:RP-191196->RP-191814; 14/1/20: WID:RP-191814->RP-192447; 26/3/20: WID:RP-192447->RP-200103; 28/7/20: WID:RP-200103->RP-200658
- 2394: basket WI; TR 38.716-04-01; 28/7/20: 0%->100
- 2395: basket WI; 28/7/20: 0%->100
- 2396: 8/10/19: WID:RP-191595->RP-192009
- 2397: 26/3/20: 0%->100
- 2398: 26/3/20: 0%->100
- 2399: no Perf. part
- 2400: no Perf. part; 8/10/19: WID:RP-191606->RP-192349; 14/1/20: WID:RP-192349->RP-192822; 26/3/20: 0%->100
- 2401: max. 2 NR bands for DL and UL; min. 1 NR FR2 band; TR 37.716-xx-xx; 8/10/19: WID:RP-191598->RP-191882; 14/1/20: WID:RP-191882->RP-192537; 26/3/20: WID:RP-192537->RP-200110; 28/7/20: WID:RP-200110->RP-201254
- 2402: max. 2 NR bands for DL and UL; min. 1 NR FR2 band; TR 37.716-xx-xx; 28/7/20: 0%->100
- 2403: max. 2 NR bands for DL and UL; min. 1 NR FR2 band; 28/7/20: 0%->100
- 2404: no Perf. part as no Perf. part objectives; NR FDD bands are based on NR SDL/SUL bands; framework part will consider interworking with LTE but without normative changes (they may follow later in EN-DC basket WIs; 8/10/19: WID:RP-191567->RP-192285; 14/1
- 2405: no Perf. part as no Perf. part objectives; NR FDD bands are based on NR SDL/SUL bands; framework part will consider interworking with LTE but without normative changes (they may follow later in EN-DC basket WIs; 8/10/19: WID:RP-191567->RP-192285; 14/1
- 2406: 14/1/20: 0%->100
- 2407: no Perf. Part; note: Some combinations were removed from REL-15 due to missing Pc,max; the combinations will be covered in existing REL-16 basket Wis once Pc,max is specified in this WI
- 2408: no Perf. Part; note: Some combinations were removed from REL-15 due to missing Pc,max; the combinations will be covered in existing REL-16 basket Wis once Pc,max is specified in this WI; 8/10/19: WID:RP-191604->RP-192093
- 2409: tested: REL-16 WI DC_Pcmax_3UL_CC-Core; 22/3/22: Compl:0%->71%; ;
- 2411: 28/7/20: 0%->100; 28/7/20: 0%->100
- 2412: -

| ID | WBS | Task | Duration | Start | Finish | Complete | Remaining | Total slack | Constraint | Resources | Work | Actual work | Acronym | PCG approved | WI rapporteur name | Release | TSG approved | WI rapporteur e-mail | Status Report |
| --- | --- | --- | --- | --- | --- | --- | --- | --- | --- | --- | --- | --- | --- | --- | --- | --- | --- | --- | --- |
| 2413 | 995 | **Over the air (OTA) base station (BS) testing TR** | 65d | 2019-03-07 A | 2019-06-05 A | 100% |  |  |  | R4 | 1040h | 1040h | OTA_BS_testing | 44 | Huawei | Rel-16 | 86 |  |  |
| 2414 | 995.1 | Perf. Part: Over the air (OTA) base station (BS) testing TR | 65d | 2019-03-07 A | 2019-06-05 A | 100% |  |  |  | R4 | 520h | 520h | OTA_BS_testing-Perf | 44 | Huawei | Rel-16 | 86 |  |  |
| 2415 | 996 | **High power UE (power class 2) for EN-DC (1 LTE FDD band + 1 NR TDD band)** | 526d | 2019-12-16 A | 2021-12-17 A | 100% |  |  |  | R4 | 7336h | 7336h | ENDC_UE_PC2_FDD_TDD | 44 | China Unicom | Rel-16 | 86 |  |  |
| 2416 | 996.1 | Core part: High power UE (power class 2) for EN-DC (1 LTE FDD band + 1 NR TDD band) | 65d | 2019-12-16 A | 2020-03-13 A | 100% |  |  | finish no earlier than 2020-03-15 | R4 | 520h | 520h | ENDC_UE_PC2_FDD_TDD-Core | 44 | China Unicom | Rel-16 | 86 |  |  |
| 2417 | 996.2 | UE Conformance Test Aspects - High power UE (power class 2) for EN-DC (1 LTE FDD band + 1 NR TDD band) | 327d | 2020-09-17 A | 2021-12-17 A | 100% |  |  | finish no earlier than 2021-12-17 | R5 | 2616h | 2616h | ENDC_UE_PC2_FDD_TDD-UEConTest | 45 | China Unicom | Rel-16 | 89 |  |  |
| 2418 | 997 | **Dual Connectivity (EN-DC) of LTE inter-band CA xDL/1UL bands (x=2,3,4) and NR FR1 1DL/1UL band and NR FR2 1DL/1UL band** | 65d | 2019-12-16 A | 2020-03-13 A | 100% |  |  |  | R4 | 1560h | 1560h | DC_R16_xBLTE_2BNR_yDL3UL | 44 | NTT DOCOMO | Rel-16 | 86 |  |  |
| 2419 | 997.1 | Core part: Dual Connectivity (EN-DC) of LTE inter-band CA xDL/1UL bands (x=2,3,4) and NR FR1 1DL/1UL band and NR FR2 1DL/1UL band | 65d | 2019-12-16 A | 2020-03-13 A | 100% |  |  | finish no earlier than 2020-03-15 | R4 | 520h | 520h | DC_R16_xBLTE_2BNR_yDL3UL-Core | 44 | NTT DOCOMO | Rel-16 | 86 |  |  |
| 2420 | 997.2 | Perf. part: Dual Connectivity (EN-DC) of LTE inter-band CA xDL/1UL bands (x=2,3,4) and NR FR1 1DL/1UL band and NR FR2 1DL/1UL band | 65d | 2019-12-16 A | 2020-03-13 A | 100% |  |  | finish no earlier than 2020-03-15 | R4 | 520h | 520h | DC_R16_xBLTE_2BNR_yDL3UL-Perf | 44 | NTT DOCOMO | Rel-16 | 86 |  |  |
| 2421 | 998 | **LTE/NR spectrum sharing in band 48/n48 frequency range** | 65d | 2019-12-16 A | 2020-03-13 A | 100% |  |  |  | R4 | 1040h | 1040h | NR_n48_LTE_48_coex | 44 | Apple | Rel-16 | 86 |  |  |
| 2422 | 998.1 | Core part: LTE/NR spectrum sharing in band 48/n48 frequency range | 65d | 2019-12-16 A | 2020-03-13 A | 100% |  |  | finish no earlier than 2020-03-15 | R4 | 520h | 520h | NR_n48_LTE_48_coex-Core | 44 | Apple | Rel-16 | 86 |  |  |
| 2423 | 999 | **LTE-NR & NR-NR Dual Connectivity and NR Carrier Aggregation enhancements** | 1299d? | 2018-06-15 A | 2023-06-06 | 99% | 0d? | 0d |  | R2 | 22368h | 13764.4h | LTE_NR_DC_CA_enh | 41 | Ericsson | Rel-16 | 80 |  |  |
| 2424 | 999.1 | Core part: LTE-NR & NR-NR Dual Connectivity and NR CA enhancements | 391d? | 2018-06-15 A | 2019-12-13 A | 100% |  |  | finish no earlier than 2019-12-15 | R2 | 3128h | 3128h | LTE_NR_DC_CA_enh-Core | 41 | Ericsson | Rel-16 | 80 |  |  |
| 2425 | 999.2 | Perf. part: LTE-NR & NR-NR Dual Connectivity and NR CA enhancements | 522d? | 2018-06-15 A | 2020-06-15 A | 100% |  |  | finish no earlier than 2020-06-15 | R4 | 4176h | 4176h | LTE_NR_DC_CA_enh-Perf | 41 | Ericsson | Rel-16 | 80 |  |  |
| 2426 | 999.3 | UE Conformance Test Aspects - LTE-NR & NR-NR Dual Connectivity and NR CA enhancements | 584d | 2021-03-12 A | 2023-06-06 A | 100% |  |  | finish no earlier than 2023-06-06 | R5 | 4672h | 4672h | LTE_NR_DC_CA_enh-UEConTest | 46 | Matti Kangas | Rel-16 | 91 | matti.kangas@nokia.com | RP-230915 |
| 2427 | 1000 | **High power UE (power class 2) for EN-DC (1 LTE TDD band + 1 NR TDD band)** | 330d | 2018-12-13 A | 2020-03-18 A | 100% |  |  |  | R4 | 10064h | 10064h | ENDC_UE_PC2_TDD_TDD | 42 | CMCC | Rel-16 | 82 |  |  |
| 2428 | 1000.1 | Study on high power UE (power class 2) for EN-DC (1 LTE FDD band + 1 NR TDD band) | 134d | 2018-12-13 A | 2019-06-18 A | 100% |  |  | start no earlier than 2018-12-13 | R4 | 1072h | 1072h | FS_ENDC_UE_PC2_FDD_TDD | 42 | China Unicom | Rel-16 | 82 |  |  |
| 2429 | 1000.2 | Core part: High power UE (power class 2) for EN-DC (1 LTE TDD band + 1 NR TDD band) | 262d | 2018-12-13 A | 2019-12-13 A | 100% |  |  | start no earlier than 2018-12-13 | R4 | 2096h | 2096h | ENDC_UE_PC2_TDD_TDD-Core | 42 | CMCC | Rel-16 | 82 |  |  |
| 2430 | 1000.3 | Perf. part: Power class 2 UE for EN-DC (1 LTE TDD band + 1 NR TDD band) | 262d | 2018-12-13 A | 2019-12-13 A | 100% |  |  | start no earlier than 2018-12-13 | R4 | 2096h | 2096h | ENDC_UE_PC2_TDD_TDD-Perf | 42 | CMCC | Rel-16 | 82 |  |  |
| 2431 | 1000.4 | UE Conformance Test Aspects - High power UE (power class 2) for EN-DC (1 LTE TDD band + 1 NR TDD band) | 270d | 2019-03-07 A | 2020-03-18 A | 100% |  |  | finish no earlier than 2020-03-18 | R5 | 2160h | 2160h | ENDC_UE_PC2_TDD_TDD-UEConTest | 44 | CMCC | Rel-16 | 87 |  |  |
| 2432 | 1001 | **eNB(s) Architecture Evolution for E-UTRAN and NG-RAN** | 457d? | 2018-03-15 A | 2019-12-13 A | 100% |  |  |  | R3 | 7312h | 7312h | LTE_NR_arch_evo | 40 | China Unicom | Rel-16 | 79 |  |  |
| 2433 | 1001.1 | Core part: eNB(s) Architecture Evolution for E-UTRAN and NG-RAN | 457d? | 2018-03-15 A | 2019-12-13 A | 100% |  |  | finish no earlier than 2019-12-15 | R3 | 3656h | 3656h | LTE_NR_arch_evo-Core | 40 | China Unicom | Rel-16 | 79 |  |  |
| 2434 | 1002 | **LTE/NR spectrum sharing in Band 41/n41 frequency range** | 134d | 2018-12-13 A | 2019-06-18 A | 100% |  |  |  | R4 | 2144h | 2144h | NR_n41_LTE_41_coex | 42 | KDDI | Rel-16 | 82 |  |  |
| 2435 | 1002.1 | Core part: LTE/NR spectrum sharing in Band 41/n41 frequency range | 134d | 2018-12-13 A | 2019-06-18 A | 100% |  |  | start no earlier than 2018-12-13 | R4 | 1072h | 1072h | NR_n41_LTE_41_coex-Core | 42 | KDDI | Rel-16 | 82 |  |  |
| 2436 | 1003 | **29 dBm UE Power Class for LTE band 41 and NR Band n41** | 1166d? | 2018-06-15 A | 2022-12-01 | 99% | 0d? | 0d |  | R4 | 14472h | 7240h | LTE_NR_B41_Bn41_PC29dBm | 41 | Sprint | Rel-16 | 80 |  |  |
| 2437 | 1003.1 | Core part: 29 dBm UE Power Class for LTE band 41 and NR Band n41 | 261d? | 2018-06-15 A | 2019-06-14 A | 100% |  |  | finish no earlier than 2019-06-15 | R4 | 2088h | 2088h | LTE_NR_B41_Bn41_PC29dBm-Core | 41 | Sprint | Rel-16 | 80 |  |  |
| 2438 | 1003.2 | UE Conformance Test Aspects - 29 dBm UE Power Class for LTE Band 41 and NR Band n41 | 383d | 2021-06-15 A | 2022-12-01 A | 100% |  |  | finish no earlier than 2022-12-01 | R5 | 3064h | 3064h | LTE_NR_B41_Bn41_PC29dBm-UEConTest | 47 | Dan SONG, CMCC, T-Mobile | Rel-16 | 92 | songdan@chinamobile.com | RP-223059 |

Notes:
- 2413: affects: UTRA, LTE, NR. no Core part; note: WI will introduce TR 37.9xx for REL-15 and REL-16
- 2414: affects: UTRA, LTE, NR. no Core part; note: WI will introduce TR 37.9xx for REL-15 and REL-16; 26/3/20: WID:RP-193225->RP-200276; 28/7/20: WID:RP-200276->RP-201021; 25/9/20: 37.941 added;; 6/1/21: 0%->100 / Impacted TSs and TRs: 37.941
- 2415: affects: LTE, NR. no Perf. part
- 2416: affects: LTE, NR. no Perf. part; 25/9/20: WID:RP-193244->RP-201578; 25/9/20: 0%->100
- 2417: tested: REL-16 WI ENDC_UE_PC2_FDD_TDD-Core ; 8/4/21: 0%->78; 29/9/21: WID:RP-201776->RP-212501; 29/9/21: 78%->100
- 2418: affects: LTE, NR. basket WI; suggested TR 37.716-41-22; 26/3/20: WID:RP-192784->RP-200228; 28/7/20: WID:RP-200228->RP-200905
- 2419: affects: LTE, NR. basket WI; suggested TR 37.716-41-22; 28/7/20: 0%->100; 25/9/20: 37.716-41-22 added; / Impacted TSs and TRs: 37.716-41-22
- 2420: affects: LTE, NR.; 28/7/20: 0%->100
- 2421: affects: LTE, NR. no Perf. part; 26/3/20: WID:RP-193213->RP-200234; 28/7/20: WID:RP-200234->RP-201359; 25/9/20: WID:RP-201359->RP-201858
- 2422: affects: LTE, NR. no Perf. part; 6/1/21: 0%->100
- 2423: RAN3 impact?¦26/3/19: WID:RP-181469->RP-190452; 26/6/19: WID:RP-190452->RP-191600; 8/10/19: WID:RP-191600->RP-192336; 28/7/20: WID:RP-192336->RP-200791
- 2424: RAN3 impact?¦26/3/19: WID:RP-181469->RP-190452; 25/9/20: 0%->100
- 2425: 26/3/19: WID:RP-181469->RP-190452; 2/7/21: 0%->100
- 2426: lested: REL-16 WI LTE_NR_DC_CA_enh-Core ; 2/7/21: WID:RP-210746->RP-211442; 2/7/21: 0%->5; 5/4/22: WID:RP-211442->RP-220801; 20/6/22: FCD:11/03/2022->22/12/2022; Compl:5%->40%; WID: RP-220801->RP-211442; Stat Rep: ->RP-221416; Rapporteur: Nokia->Matti...; 9/8/23: WID:RP-222021->RP-231105
- 2427: 26/3/19: WID:RP-182877->RP-190315
- 2428: EN-DC = E-UTRA-NR Dual Connectivity¦TR 37.8xx¦26/3/19: WID:RP-182895->RP-190167; 8/10/19: WID:RP-190167->RP-192268; 14/1/20: 0%->100
- 2429: 26/3/19: WID:RP-182877->RP-190315; 14/1/20: 0%->100
- 2430: 26/3/19: WID:RP-182877->RP-190315; 14/1/20: 0%->100
- 2431: affects: NR. TR 38.8xx; 28/7/20: WID:RP-200434->RP-200761; 25/9/20: WID:RP-200761->RP-202066; 25/9/20: 0%->100
- 2432: follow-up WI of REL-15 SI FS_LTE_arch_evo; 14/1/20: WID:RP-180531->RP-192917
- 2433: follow-up WI of REL-15 SI FS_LTE_arch_evo¦27/6/18: Compl:0%->15%¦27/6/18: CD:Fri 15/06/18->Sun 15/12/19¦27/6/18: WID: RP-180531->RP-181375¦27/6/18: Release: Rel-15->Rel-16¦6/8/18: 37.470 to 473 and 36.470 to 473 added;; 14/1/20: 15%->100 / Impacted TSs and TRs: 37.470; 37.471; 37.472; 37.473; 36.470; 36.471; 36.472; 36.473
- 2434: no Perf. part¦changes will happen only on NR side¦26/3/19: WID:RP-182883->RP-190175; 26/6/19: WID:RP-190175->RP-191588
- 2435: no Perf. part¦changes will happen only on NR side¦26/3/19: WID:RP-182883->RP-190175; 26/6/19: 0%->100
- 2436: no Perf. part¦26/3/19: WID:RP-181655->RP-190502; 14/1/20: WID:RP-190502->RP-192738; 28/7/20: WID:RP-192738->RP-201134
- 2437: no Perf. part¦7/3/19: WID:RP-181460->RP-181655¦26/3/19: WID:RP-181655->RP-190502; 25/9/20: 0%->100; 25/9/20: 100%->100
- 2438: tested: REL-17 WI LTE_NR_B41_Bn41_PC29dBm-Core ; 5/4/22: WID:RP-211443->RP-220124 6/6/22: C ; 20/6/22: Stat Rep: R5-222679->RP-221180 / R5-222679; Rapporteur: T-Mobile USA->Scott Probasco, Dan SONG, T-Mobile, CMCC; Rap eMail: ->scott.probasco@t-mobile....; 9/1/23: 100%->100

| ID | WBS | Task | Type | Duration | Start | Finish | Complete | Constraint | Resources | Work | Actual work | PCG approved | Release | TSG approved | Acronym | WI rapporteur name | Impacted TSs and TRs |
| --- | --- | --- | --- | --- | --- | --- | --- | --- | --- | --- | --- | --- | --- | --- | --- | --- | --- |
| 2439 | 1004 | **Dual Connectivity (EN-DC)** |  | 391d? | 2018-06-15 A | 2019-12-13 A | 100% |  |  | 56304h | 56304h | 41 | Rel-16 | 80 |  |  |  |
| 2440 | 1004.1 | **Dual Connectivity (EN-DC) of 1 LTE band (1UL/1DL) and 1 NR band (1DL/1UL)** |  | 391d? | 2018-06-15 A | 2019-12-13 A | 100% |  | R4 | 9384h | 9384h | 41 | Rel-16 | 80 | DC_R16_1BLTE_1BNR_2DL2UL | NTT DOCOMO |  |
| 2441 | 1004.1.1 | Core part: Dual Connectivity (EN-DC) of 1 LTE band (1UL/1DL) and 1 NR band (1DL/1UL) |  | 391d? | 2018-06-15 A | 2019-12-13 A | 100% | start no earlier than 2018-06-15 | R4 | 3128h | 3128h | 41 | Rel-16 | 80 | DC_R16_1BLTE_1BNR_2DL2UL-Core | NTT DOCOMO |  |
| 2442 | 1004.1.2 | Perf. part: Dual Connectivity (EN-DC) of 1 LTE band (1UL/1DL) and 1 NR band (1DL/1UL) |  | 391d? | 2018-06-15 A | 2019-12-13 A | 100% | finish no earlier than 2019-12-15 | R4 | 3128h | 3128h | 41 | Rel-16 | 80 | DC_R16_1BLTE_1BNR_2DL2UL-Perf | NTT DOCOMO |  |
| 2443 | 1004.2 | **Dual Connectivity (EN-DC) of 2 bands LTE inter-band CA (2DL/1UL) and 1 NR band (1DL/1UL)** |  | 391d? | 2018-06-15 A | 2019-12-13 A | 100% |  | R4 | 9384h | 9384h | 41 | Rel-16 | 80 | DC_R16_2BLTE_1BNR_3DL2UL | Huawei |  |
| 2444 | 1004.2.1 | Core part: Dual Connectivity (EN-DC) of 2 bands LTE inter-band CA (2DL/1UL) and 1 NR band (1DL/1UL) |  | 391d? | 2018-06-15 A | 2019-12-13 A | 100% | finish no earlier than 2019-12-15 | R4 | 3128h | 3128h | 41 | Rel-16 | 80 | DC_R16_2BLTE_1BNR_3DL2UL-Core | Huawei |  |
| 2445 | 1004.2.2 | Perf. part: Dual Connectivity (EN-DC) of 2 bands LTE inter-band CA (2DL/1UL) and 1 NR band (1DL/1UL) |  | 391d? | 2018-06-15 A | 2019-12-13 A | 100% | finish no earlier than 2019-12-15 | R4 | 3128h | 3128h | 41 | Rel-16 | 80 | DC_R16_2BLTE_1BNR_3DL2UL-Perf | Huawei |  |
| 2446 | 1004.3 | **Dual Connectivity (EN-DC) of 3 bands LTE inter-band CA (3DL/1UL) and 1 NR band (1DL/1UL)** |  | 391d? | 2018-06-15 A | 2019-12-13 A | 100% |  | R4 | 9384h | 9384h | 41 | Rel-16 | 80 | DC_R16_3BLTE_1BNR_4DL2UL | Ericsson |  |
| 2447 | 1004.3.1 | Core part: Dual Connectivity (EN-DC) of 3 bands LTE inter-band CA (3DL/1UL) and 1 NR band (1DL/1UL) |  | 391d? | 2018-06-15 A | 2019-12-13 A | 100% | finish no earlier than 2019-12-15 | R4 | 3128h | 3128h | 41 | Rel-16 | 80 | DC_R16_3BLTE_1BNR_4DL2UL-Core | Ericsson |  |
| 2448 | 1004.3.2 | Perf. part: Dual Connectivity (EN-DC) of 3 bands LTE inter-band CA (3DL/1UL) and 1 NR band (1DL/1UL) |  | 391d? | 2018-06-15 A | 2019-12-13 A | 100% | finish no earlier than 2019-12-15 | R4 | 3128h | 3128h | 41 | Rel-16 | 80 | DC_R16_3BLTE_1BNR_4DL2UL-Perf | Ericsson |  |
| 2449 | 1004.4 | **Dual Connectivity (EN-DC) of 4 bands LTE inter-band CA (4DL/1UL) and 1 NR band (1DL/1UL)** |  | 391d? | 2018-06-15 A | 2019-12-13 A | 100% |  | R4 | 9384h | 9384h | 41 | Rel-16 | 80 | DC_R16_4BLTE_1BNR_5DL2UL | Nokia |  |
| 2450 | 1004.4.1 | Core part: Dual Connectivity (EN-DC) of 4 bands LTE inter-band CA (4DL/1UL) and 1 NR band (1DL/1UL) |  | 391d? | 2018-06-15 A | 2019-12-13 A | 100% | finish no earlier than 2019-12-15 | R4 | 3128h | 3128h | 41 | Rel-16 | 80 | DC_R16_4BLTE_1BNR_5DL2UL-Core | Nokia |  |
| 2451 | 1004.4.2 | Perf. part: Dual Connectivity (EN-DC) of 4 bands LTE inter-band CA (4DL/1UL) and 1 NR band (1DL/1UL) |  | 391d? | 2018-06-15 A | 2019-12-13 A | 100% | finish no earlier than 2019-12-15 | R4 | 3128h | 3128h | 41 | Rel-16 | 80 | DC_R16_4BLTE_1BNR_5DL2UL-Perf | Nokia |  |
| 2452 | 1004.5 | **Dual Connectivity (EN-DC) of 5 bands LTE inter-band CA (5DL/1UL) and 1 NR band (1DL/1UL)** |  | 391d? | 2018-06-15 A | 2019-12-13 A | 100% |  | R4 | 9384h | 9384h | 41 | Rel-16 | 80 | DC_R16_5BLTE_1BNR_6DL2UL | Samsung |  |
| 2453 | 1004.5.1 | Stopped : Core part: Dual Connectivity (EN-DC) of 5 bands LTE inter-band CA (5DL/1UL) and 1 NR band (1DL/1UL) |  | 391d? | 2018-06-15 A | 2019-12-13 A | 100% | finish no earlier than 2019-12-15 | R4 | 3128h | 3128h | 41 | Rel-16 | 80 | DC_R16_5BLTE_1BNR_6DL2UL-Core | Samsung |  |
| 2454 | 1004.5.2 | Stopped: Perf. part: Dual Connectivity (EN-DC) of 5 bands LTE inter-band CA (5DL/1UL) and 1 NR band (1DL/1UL) |  | 391d? | 2018-06-15 A | 2019-12-13 A | 100% | finish no earlier than 2019-12-15 | R4 | 3128h | 3128h | 41 | Rel-16 | 80 | DC_R16_5BLTE_1BNR_6DL2UL-Perf | Samsung |  |
| 2455 | 1004.6 | **Dual Connectivity (EN-DC) of x bands (x=1, 2, 3, 4) LTE inter-band CA (xDL/1UL) and 2 bands NR inter-band CA (2DL/1UL)** |  | 391d? | 2018-06-15 A | 2019-12-13 A | 100% |  | R4 | 9384h | 9384h | 41 | Rel-16 | 80 | DC_R16_xBLTE_2BNR_yDL2UL | LG Electronics |  |
| 2456 | 1004.6.1 | Core part: Dual Connectivity (EN-DC) of x bands (x=2, 3, 4) LTE inter-band CA (xDL/1UL) and 2 bands NR inter-band CA (2DL/1UL) |  | 391d? | 2018-06-15 A | 2019-12-13 A | 100% | finish no earlier than 2019-12-15 | R4 | 3128h | 3128h | 41 | Rel-16 | 80 | DC_R16_xBLTE_2BNR_yDL2UL-Core | LG Electronics |  |
| 2457 | 1004.6.2 | Perf. part: Dual Connectivity (EN-DC) of x bands (x=2, 3, 4) LTE inter-band CA (xDL/1UL) and 2 bands NR inter-band CA (2DL/1UL) |  | 391d? | 2018-06-15 A | 2019-12-13 A | 100% | finish no earlier than 2019-12-15 | R4 | 3128h | 3128h | 41 | Rel-16 | 80 | DC_R16_xBLTE_2BNR_yDL2UL-Perf | LG Electronics |  |
| 2458 | 1005 | LTE-related Release 16 Features | milestone | 0d? | 2016-06-09 A | 2016-06-09 A | 100% | finish no earlier than 2016-06-09 |  |  |  |  | Rel-16 |  |  |  |  |
| 2459 | 1006 | **E-UTRA 2.4 GHz TDD Band for US** |  | 329d? | 2018-03-15 A | 2019-06-18 A | 100% |  | R4 | 5800h | 5800h | 40 | Rel-16 | 79 | LTE_TDD_2400_US | Globalstar | 36.791 |
| 2460 | 1006.1 | Core part: E-UTRA 2.4 GHz TDD Band for US |  | 197d? | 2018-03-15 A | 2018-12-14 A | 100% | finish no earlier than 2018-12-15 | R4 | 1576h | 1576h | 40 | Rel-16 | 79 | LTE_TDD_2400_US-Core | Globalstar | 36.791 |
| 2461 | 1006.2 | Perf. part: E-UTRA 2.4 GHz TDD Band for US |  | 197d? | 2018-03-15 A | 2018-12-14 A | 100% | finish no earlier than 2018-12-15 | R4 | 1576h | 1576h | 40 | Rel-16 | 79 | LTE_TDD_2400_US-Perf | Globalstar |  |
| 2462 | 1006.3 | UE Conformance Test Aspects - E-UTRA 2.4 GHz TDD Band for US (Band 53) |  | 134d | 2018-12-13 A | 2019-06-18 A | 100% | start no earlier than 2018-12-13 | R5 | 1072h | 1072h | 42 | Rel-15 | 82 | LTE_TDD_2400_US-UEConTest | Globalstar |  |

Notes:
- 2440: basket WI¦TR 37.716-01-01¦16/1/19: WID:RP-181447->RP-182567¦26/3/19: WID:RP-182567->RP-190705; 26/6/19: WID:RP-190705->RP-191568; 8/10/19: WID:RP-191568->RP-191752; 14/1/20: WID:RP-191752->RP-192742; 26/3/20: WID:RP-192742->RP-200221; 28/7/20: WID:RP-2
- 2441: basket WI¦TR 37.716-01-01¦26/3/19: WID:RP-182567->RP-190705; 28/7/20: 0%->100
- 2442: basket WI¦26/3/19: WID:RP-182567->RP-190705; 28/7/20: 0%->100
- 2443: basket WI¦TR 37.716-02-01¦16/1/19: WID:RP-181357->RP-182557¦26/3/19: WID:RP-182557->RP-190379; 26/6/19: WID:RP-190379->RP-191124; 8/10/19: WID:RP-191124->RP-192087; 14/1/20: WID:RP-192087->RP-192815; 26/3/20: WID:RP-192815->RP-200271; 28/7/20: WID:RP-2
- 2444: basket WI¦TR 37.716-02-01¦26/3/19: WID:RP-182557->RP-190379; 28/7/20: 0%->100
- 2445: basket WI¦26/3/19: WID:RP-182557->RP-190379; 28/7/20: 0%->100
- 2446: basket WI¦TR 37.716-03-01¦16/1/19: WID:RP-181407->RP-182257¦26/3/19: WID:RP-182257->RP-190159; 26/6/19: WID:RP-190159->RP-191195; 8/10/19: WID:RP-191195->RP-191813; 14/1/20: WID:RP-191813->RP-192446; 26/3/20: WID:RP-192446->RP-200102; 28/7/20: WID:RP-2
- 2447: basket WI¦TR 37.716-03-01¦26/3/19: WID:RP-182257->RP-190159; 28/7/20: 0%->100
- 2448: basket WI¦26/3/19: WID:RP-182257->RP-190159; 28/7/20: 0%->100
- 2449: basket WI¦TR 37.716-04-01¦16/1/19: WID:RP-181001->RP-182534¦26/3/19: WID:RP-182534->RP-190294; 26/6/19: WID:RP-190294->RP-191205; 8/10/19: WID:RP-191205->RP-191728; 14/1/20: WID:RP-191728->RP-192768; 26/3/20: WID:RP-192768->RP-200134; 28/7/20: WID:RP-2
- 2450: basket WI¦TR 37.716-04-01¦26/3/19: WID:RP-182534->RP-190294; 28/7/20: 0%->100
- 2451: basket WI¦26/3/19: WID:RP-182534->RP-190294; 28/7/20: 0%->100
- 2452: basket WI¦TR 37.716-05-01
- 2453: basket WI¦TR 37.716-05-01; 14/1/20: 0%->100
- 2454: basket WI; 14/1/20: 0%->100
- 2455: basket WI¦TR 37.716-00-02¦16/1/19: WID:RP-180777->RP-182302, "x=1" added¦26/3/19: WID:RP-182302->RP-190151; 26/6/19: WID:RP-190151->RP-190949; 8/10/19: WID:RP-190949->RP-191744; 14/1/20: WID:RP-191744->RP-192592; 26/3/20: WID:RP-192592->RP-200080; 28/7
- 2456: basket WI¦TR 37.716-00-02¦26/3/19: WID:RP-182302->RP-190151; 28/7/20: 0%->100
- 2457: basket WI¦26/3/19: WID:RP-182302->RP-190151; 28/7/20: 0%->100
- 2458: -
- 2459: new LTE TDD band for 2483.5 to 2495MHz¦compare band 41: 2,496-2,69GHz introduced by WI LTE_TDD_2600_US¦6/8/18: 36.791 added;¦16/1/19: WID:RP-180583->RP-182405
- 2460: new LTE TDD band for 2483.5 to 2495MHz¦compare band 41: 2,496-2,69GHz introduced by WI LTE_TDD_2600_US¦6/8/18: 36.791 added;¦16/1/19: 0%->100
- 2461: new LTE TDD band for 2483.5 to 2495MHz¦compare band 41: 2,496-2,69GHz introduced by WI LTE_TDD_2600_US¦16/1/19: 0%->100
- 2462: tested: REL-15 WI LTE_TDD_2400_US-Core; 26/6/19: 0%->100

| ID | WBS | Task | Duration | Start | Finish | Complete | Remaining | Total slack | Constraint | Resources | Work | Actual work | PCG approved | Release | TSG approved | Acronym | WI rapporteur name | WI rapporteur e-mail | Status Report | Impacted TSs and TRs |
| --- | --- | --- | --- | --- | --- | --- | --- | --- | --- | --- | --- | --- | --- | --- | --- | --- | --- | --- | --- | --- |
| 2463 | 1007 | **LTE intra-band Carrier Aggregation (CA)** | 1180d? | 2018-06-15 A | 2022-12-21 | 82% | 210.71d? | 837d |  |  | 65224h | 56304h | 41 | Rel-16 | 80 |  |  |  |  |  |
| 2464 | 1007.1 | **Rel-16 LTE intra-band CA for x CC DL/y CC UL including contiguous and non-contiguous spectrum (x>=y)** | 391d? | 2018-06-15 A | 2019-12-13 A | 100% |  |  |  | R4 | 9384h | 9384h | 41 | Rel-16 | 80 | LTE_CA_R16_intra | Ericsson |  |  |  |
| 2465 | 1007.1.1 | Core part: Rel-16 LTE intra-band CA for x CC DL/y CC UL including contiguous and non-contiguous spectrum (x>=y) | 391d? | 2018-06-15 A | 2019-12-13 A | 100% |  |  | start no earlier than 2018-06-15 | R4 | 3128h | 3128h | 41 | Rel-16 | 80 | LTE_CA_R16_intra-Core | Ericsson |  |  |  |
| 2466 | 1007.1.2 | Perf. part: Rel-16 LTE intra-band CA for x CC DL/y CC UL including contiguous and non-contiguous spectrum (x>=y) | 391d? | 2018-06-15 A | 2019-12-13 A | 100% |  |  | finish no earlier than 2019-12-15 | R4 | 3128h | 3128h | 41 | Rel-16 | 80 | LTE_CA_R16_intra-Perf | Ericsson |  |  |  |
| 2467 | 1007.2 | **Rel-16 LTE inter-band CA for 2 bands DL with 1 band UL** | 391d? | 2018-06-15 A | 2019-12-13 A | 100% |  |  |  | R4 | 9384h | 9384h | 41 | Rel-16 | 80 | LTE_CA_R16_2BDL_1BUL | Qualcomm |  |  |  |
| 2468 | 1007.2.1 | Core part: Rel-16 LTE inter-band CA for 2 bands DL with 1 band UL | 391d? | 2018-06-15 A | 2019-12-13 A | 100% |  |  | finish no earlier than 2019-12-15 | R4 | 3128h | 3128h | 41 | Rel-16 | 80 | LTE_CA_R16_2BDL_1BUL-Core | Qualcomm |  |  |  |
| 2469 | 1007.2.2 | Perf. part: Rel-16 LTE inter-band CA for 2 bands DL with 1 band UL | 391d? | 2018-06-15 A | 2019-12-13 A | 100% |  |  | finish no earlier than 2019-12-15 | R4 | 3128h | 3128h | 41 | Rel-16 | 80 | LTE_CA_R16_2BDL_1BUL-Perf | Qualcomm |  |  |  |
| 2470 | 1007.3 | **Rel-16 LTE inter-band CA for 3 bands DL with 1 band UL** | 391d? | 2018-06-15 A | 2019-12-13 A | 100% |  |  |  | R4 | 9384h | 9384h | 41 | Rel-16 | 80 | LTE_CA_R16_3BDL_1BUL | Huawei |  |  |  |
| 2471 | 1007.3.1 | Core part: Rel-16 LTE inter-band CA for 3 bands DL with 1 band UL | 391d? | 2018-06-15 A | 2019-12-13 A | 100% |  |  | finish no earlier than 2019-12-15 | R4 | 3128h | 3128h | 41 | Rel-16 | 80 | LTE_CA_R16_3BDL_1BUL-Core | Huawei |  |  |  |
| 2472 | 1007.3.2 | Perf. part: Rel-16 LTE inter-band CA for 3 bands DL with 1 band UL | 391d? | 2018-06-15 A | 2019-12-13 A | 100% |  |  | finish no earlier than 2019-12-15 | R4 | 3128h | 3128h | 41 | Rel-16 | 80 | LTE_CA_R16_3BDL_1BUL-Perf | Huawei |  |  |  |
| 2473 | 1007.4 | **Rel-16 LTE inter-band CA for x bands DL (x=4, 5) with 1 band UL** | 391d? | 2018-06-15 A | 2019-12-13 A | 100% |  |  |  | R4 | 9384h | 9384h | 41 | Rel-16 | 80 | LTE_CA_R16_xBDL_1BUL | Nokia |  |  |  |
| 2474 | 1007.4.1 | Core part: Rel-16 LTE inter-band CA for x bands DL (x=4, 5) with 1 band UL | 391d? | 2018-06-15 A | 2019-12-13 A | 100% |  |  | finish no earlier than 2019-12-15 | R4 | 3128h | 3128h | 41 | Rel-16 | 80 | LTE_CA_R16_xBDL_1BUL-Core | Nokia |  |  |  |
| 2475 | 1007.4.2 | Perf. part: Rel-16 LTE inter-band CA for x bands DL (x=4, 5) with 1 band UL | 391d? | 2018-06-15 A | 2019-12-13 A | 100% |  |  | finish no earlier than 2019-12-15 | R4 | 3128h | 3128h | 41 | Rel-16 | 80 | LTE_CA_R16_xBDL_1BUL-Perf | Nokia |  |  |  |
| 2476 | 1007.5 | **Rel-16 LTE inter-band CA for 2 bands DL with 2 band UL** | 391d? | 2018-06-15 A | 2019-12-13 A | 100% |  |  |  | R4 | 9384h | 9384h | 41 | Rel-16 | 80 | LTE_CA_R16_2BDL_2BUL | Huawei |  |  |  |
| 2477 | 1007.5.1 | Core part: Rel-16 LTE inter-band CA for 2 bands DL with 2 band UL | 391d? | 2018-06-15 A | 2019-12-13 A | 100% |  |  | finish no earlier than 2019-12-15 | R4 | 3128h | 3128h | 41 | Rel-16 | 80 | LTE_CA_R16_2BDL_2BUL-Core | Huawei |  |  |  |
| 2478 | 1007.5.2 | Perf. part: Rel-16 LTE inter-band CA for 2 bands DL with 2 band UL | 391d? | 2018-06-15 A | 2019-12-13 A | 100% |  |  | start no earlier than 2018-06-15 | R4 | 3128h | 3128h | 41 | Rel-16 | 80 | LTE_CA_R16_2BDL_2BUL-Perf | Huawei |  |  |  |
| 2479 | 1007.6 | **Rel-16 LTE inter-band CA for x bands DL (x= 3, 4, 5) with 2 band UL** | 391d? | 2018-06-15 A | 2019-12-13 A | 100% |  |  |  | R4 | 9384h | 9384h | 41 | Rel-16 | 80 | LTE_CA_R16_xBDL_2BUL | LG Electronics |  |  |  |
| 2480 | 1007.6.1 | Core part: Rel-16 LTE inter-band CA for x bands DL (x= 3, 4, 5) with 2 band UL | 391d? | 2018-06-15 A | 2019-12-13 A | 100% |  |  | start no earlier than 2018-06-15 | R4 | 3128h | 3128h | 41 | Rel-16 | 80 | LTE_CA_R16_xBDL_2BUL-Core | LG Electronics |  |  |  |
| 2481 | 1007.6.2 | Perf. part: Rel-16 LTE inter-band CA for x bands DL (x= 3, 4, 5) with 2 band UL | 391d? | 2018-06-15 A | 2019-12-13 A | 100% |  |  | finish no earlier than 2019-12-15 | R4 | 3128h | 3128h | 41 | Rel-16 | 80 | LTE_CA_R16_xBDL_2BUL-Perf | LG Electronics |  |  |  |
| 2482 | 1007.7 | UE Conformance Test Aspects – Rel-16 LTE CA configurations | 1115d? | 2018-09-14 A | 2022-12-21 | 7% | 1036.95d? | 837d | finish no earlier than 2022-12-22 | R5 | 8920h |  | 41 | Rel-16 | 81 | LTE_CA_R16-UEConTest | Leif MATTISSON | Leif[dot]mattisson[at]ericsson[dot]com | RP-222098 |  |
| 2483 | 1008 | **LTE-based 5G terrestrial broadcast** | 512d? | 2018-06-15 A | 2020-06-01 A | 100% |  |  |  | R1 | 9928h | 9928h | 42 | Rel-16 | 83 | LTE_terr_bcast | Qualcomm |  |  | 36.276; 36.476 |
| 2484 | 1008.1 | Study on LTE-based 5G terrestrial broadcast | 196d? | 2018-06-15 A | 2019-03-15 A | 100% |  |  | finish no earlier than 2019-03-15 | R1 | 1568h | 1568h | 41 | Rel-16 | 80 | FS_LTE_terr_bcast | Qualcomm |  |  |  |
| 2485 | 1008.2 | Core part: LTE-based 5G terrestrial broadcast | 206d | 2019-03-01 A | 2019-12-13 A | 100% |  |  | finish no earlier than 2019-12-15 | R1 | 1648h | 1648h | 42 | Rel-16 | 83 | LTE_terr_bcast-Core | Qualcomm |  |  |  |
| 2486 | 1008.3 | Perf. part: LTE-based 5G terrestrial broadcast | 327d | 2019-03-01 A | 2020-06-01 A | 100% |  |  | finish no earlier than 2020-06-01 | R4 | 2616h | 2616h | 42 | Rel-16 | 83 | LTE_terr_bcast-Perf | Qualcomm |  |  |  |

Notes:
- 2464: basket WI¦TR 36.716-01-01¦16/1/19: WID:RP-180806->SP-182255¦26/3/19: WID:RP-182255->RP-190157; 26/6/19: WID:RP-190157->RP-191193; 8/10/19: WID:RP-191193->RP-191811; 14/1/20: WID:RP-191811->RP-192444; 26/3/20: WID:RP-192444->RP-200100; 28/7/20: WID:RP-2
- 2465: basket WI¦TR 36.716-01-01¦26/3/19: WID:RP-182255->RP-190157; 28/7/20: 0%->100
- 2466: basket WI¦26/3/19: WID:RP-182255->RP-190157; 28/7/20: 0%->100
- 2467: basket WI¦TR 36.716-02-01¦16/1/19: WID:RP-181441->RP-182345¦26/3/19: WID:RP-182345->RP-190500; 26/6/19: WID:RP-190500->RP-191085; 8/10/19: WID:RP-191085->RP-191733; 14/1/20: WID:RP-191733->RP-192525; 26/3/20: WID:RP-192525->RP-200231; 28/7/20: WID:RP-2
- 2468: basket WI¦TR 36.716-02-01¦16/1/19: WID:RP-181441->RP-182345¦26/3/19: WID:RP-182345->RP-190500; 26/6/19: WID:RP-190500->RP-191085; 28/7/20: 0%->100
- 2469: basket WI¦TR 36.716-02-01¦16/1/19: WID:RP-181441->RP-182345¦26/3/19: WID:RP-182345->RP-190500; 26/6/19: WID:RP-190500->RP-191085; 28/7/20: 0%->100
- 2470: basket WI¦TR 36.716-03-01¦16/1/19: WID:RP-181436->RP-182553¦26/3/19: WID:RP-182553->RP-190375; 26/6/19: WID:RP-190375->RP-191120; 8/10/19: WID:RP-191120->RP-192083; 14/1/20: WID:RP-192083->RP-192811; 26/3/20: WID:RP-192811->RP-200451; 28/7/20: WID:RP-2
- 2471: basket WI¦TR 36.716-03-01¦26/3/19: WID:RP-182553->RP-190375; 28/7/20: 0%->100
- 2472: basket WI¦26/3/19: WID:RP-182553->; 28/7/20: 0%->100
- 2473: basket WI¦TR 36.716-04-01¦16/1/19: WID:RP-181408->RP-182330¦26/3/19: WID:RP-182330->RP-190138; 26/6/19: WID:RP-190138->RP-190906; 8/10/19: WID:RP-190906->RP-191730; 14/1/20: WID:RP-191730->RP-192423; 26/3/20: WID:RP-192423->RP-200157; 28/7/20: WID:RP-2
- 2474: basket WI¦TR 36.716-04-01¦26/3/19: WID:RP-182330->RP-190138; 28/7/20: 0%->100
- 2475: basket WI¦26/3/19: WID:RP-182330->RP-190138; 28/7/20: 0%->100
- 2476: basket WI¦TR 36.716-02-02¦16/1/19: WID:RP-181356->RP-182555¦26/3/19: WID:RP-182555->RP-190377; 8/10/19: WID:RP-190377->RP-192085; 14/1/20: WID:RP-192085->RP-192813; 26/3/20: WID:RP-192813->RP-200269; 28/7/20: WID:RP-200269->RP-201014
- 2477: basket WI¦TR 36.716-02-02¦26/3/19: WID:RP-182555->RP-190377; 28/7/20: 0%->100
- 2478: basket WI¦26/3/19: WID:RP-182555->RP-190377; 28/7/20: 0%->100
- 2479: basket WI¦TR 36.716-00-02¦16/1/19: WID:RP-180778->RP-182301¦26/3/19: WID:RP-182301->RP-190150; 26/6/19: WID:RP-190150->RP-190946; 8/10/19: WID:RP-190946->RP-191743; 14/1/20: WID:RP-191743->RP-192586; 26/3/20: WID:RP-192586->RP-200510; 28/7/20: WID:RP-2
- 2480: basket WI¦TR 36.716-00-02¦26/3/19: WID:RP-182301->RP-190150; 28/7/20: 0%->100
- 2481: basket WI¦26/3/19: WID:RP-182301->RP-190150; 28/7/20: 0%->100
- 2482: 16/1/19: WID:RP-181605->RP-182648; 8/10/20: 0%->7; 8/10/20: FCD:19/06/2020->12/20; 8/4/21: 7%->7; 8/4/21: FCD:11/12/2020->09/21; 2/7/21: 7%->; 2/7/21: FCD:Wed 08/09/->03/22; 20/6/22: FCD:11/03/2022->22/12/2022; WID: RP-182648->RP-171886; Stat Rep: ->RP...; 9/9/22: WID: RP-171886->RP-182648; 9/9/22: Stat Rep: RP-221219->RP-222098
- 2483: 8/10/19: WID:RP-190732->RP-191924; 8/10/19: 36.276 added;; 14/1/20: WID:RP-191924->RP-193050
- 2484: TR 36.7xx¦26/3/19: 0%->100
- 2485: 26/3/20: 0%->100
- 2486: 25/9/20: 0%->100

| ID | WBS | Task | Duration | Start | Finish | Complete | Remaining | Total slack | Constraint | Resources | Work | Actual work | Acronym | PCG approved | WI rapporteur name | Release | TSG approved | Status Report | WI rapporteur e-mail |
| --- | --- | --- | --- | --- | --- | --- | --- | --- | --- | --- | --- | --- | --- | --- | --- | --- | --- | --- | --- |
| 2487 | 1009 | **Power class 2 UE for LTE bands 31 and 72** | 401d | 2019-03-01 A | 2020-09-11 A | 100% |  |  |  | R4 | 7024h | 7024h | LTE_PC2_B31_B72 | 42 | Nokia | Rel-16 | 83 |  |  |
| 2488 | 1009.1 | Core part: Power class 2 UE for LTE bands 31 and 72 | 141d | 2019-03-01 A | 2019-09-13 A | 100% |  |  | finish no earlier than 2019-09-15 | R4 | 1128h | 1128h | LTE_PC2_B31_B72-Core | 42 | Nokia | Rel-16 | 83 |  |  |
| 2489 | 1009.2 | Perf. part: Power class 2 UE for LTE bands 31 and 72 | 141d | 2019-03-01 A | 2019-09-13 A | 100% |  |  | finish no earlier than 2019-09-15 | R4 | 1128h | 1128h | LTE_PC2_B31_B72-Perf | 42 | Nokia | Rel-16 | 83 |  |  |
| 2490 | 1009.3 | UE Conformance Test Aspects – Addition of Power Class 2 UE for LTE bands 31 and 72 | 195d | 2019-12-16 A | 2020-09-11 A | 100% |  |  | finish no earlier than 2020-09-12 | R5 | 1560h | 1560h | LTE_PC2_B31_B72-UEConTest | 44 | Airbus | Rel-16 | 86 |  |  |
| 2491 | 1010 | **Additional LTE bands** | 853d? | 2018-06-15 A | 2021-09-21 A | 100% |  |  |  |  | 26120h | 26120h |  | 41 |  | Rel-16 | 80 |  |  |
| 2492 | 1010.1 | **Additional LTE bands for UE category M1 and/or NB1 in Rel-16** | 853d? | 2018-06-15 A | 2021-09-21 A | 100% |  |  |  | R4 | 14624h | 14624h | LTE_bands_R16_M1_NB1 | 41 | Ericsson | Rel-16 | 80 | RP-211863 |  |
| 2493 | 1010.1.1 | Core part: Additional LTE bands for UE category M1 and/or NB1 in Rel-16 | 391d? | 2018-06-15 A | 2019-12-13 A | 100% |  |  | finish no earlier than 2019-12-15 | R4 | 3128h | 3128h | LTE_bands_R16_M1_NB1-Core | 41 | Ericsson | Rel-16 | 80 |  |  |
| 2494 | 1010.1.2 | Perf. part: Additional LTE bands for UE category M1 and/or NB1 in Rel-16 | 391d? | 2018-06-15 A | 2019-12-13 A | 100% |  |  | finish no earlier than 2019-12-15 | R4 | 3128h | 3128h | LTE_bands_R16_M1_NB1-Perf | 41 | Ericsson | Rel-16 | 80 |  |  |
| 2495 | 1010.1.3 | UE Conformance Test Aspects - Additional LTE bands for UE category M1 and/or NB1 in Rel-16 | 193d | 2020-12-14 A | 2021-09-08 A | 100% |  |  | finish no earlier than 2021-09-08 | R5 | 1544h | 1544h | LTE_bands_R16_M1_NB1-UEConTest | 46 | Ericsson | Rel-16 | 90 |  |  |
| 2496 | 1010.2 | **Additional LTE bands for UE category M2 and/or NB2 in Rel-16** | 853d? | 2018-06-15 A | 2021-09-21 A | 100% |  |  |  | R4 | 11496h | 11496h | LTE_bands_R16_M2_NB2 | 41 | Ericsson | Rel-16 | 80 | RP-211864 |  |
| 2497 | 1010.2.1 | Core part: Additional LTE bands for UE category M2 and/or NB2 in Rel-16 | 391d? | 2018-06-15 A | 2019-12-13 A | 100% |  |  | finish no earlier than 2019-12-15 | R4 | 3128h | 3128h | LTE_bands_R16_M2_NB2-Core | 41 | Ericsson | Rel-16 | 80 |  |  |
| 2498 | 1010.2.2 | UE Conformance Test Aspects - Additional LTE bands for UE category M2 and/or NB2 in Rel-16 | 193d | 2020-12-14 A | 2021-09-08 A | 100% |  |  | finish no earlier than 2021-09-08 | R5 | 1544h | 1544h | LTE_bands_R16_M2_NB2-UEConTest | 46 | Ericsson | Rel-16 | 90 |  |  |
| 2499 | 1011 | **Further performance enhancement for LTE in high speed scenario** | 391d? | 2018-06-15 A | 2019-12-13 A | 100% |  |  |  | R4 | 9384h | 9384h | LTE_high_speed_enh2 | 41 | NTT DOCOMO | Rel-16 | 80 |  |  |
| 2500 | 1011.1 | Core part: Further performance enhancement for LTE in high speed scenario | 391d? | 2018-06-15 A | 2019-12-13 A | 100% |  |  | finish no earlier than 2019-12-15 | R4 | 3128h | 3128h | LTE_high_speed_enh2-Core | 41 | NTT DOCOMO | Rel-16 | 80 |  |  |
| 2501 | 1011.2 | Perf. part: Further performance enhancement for LTE in high speed scenario | 391d? | 2018-06-15 A | 2019-12-13 A | 100% |  |  | finish no earlier than 2019-12-15 | R4 | 3128h | 3128h | LTE_high_speed_enh2-Perf | 41 | NTT DOCOMO | Rel-16 | 80 |  |  |
| 2502 | 1012 | **Cross Link Interference (CLI) handling and Remote Interference Management (RIM) for NR** | 1299d? | 2018-06-15 A | 2023-06-06 | 62% | 494.07d? | 718d |  | R1 | 20248h | 6264h | NR_CLI_RIM | 41 | LG Electronics | Rel-16 | 80 |  |  |
| 2503 | 1012.1 | Core part: Cross Link Interference (CLI) handling and Remote Interference Management (RIM) for NR | 261d? | 2018-06-15 A | 2019-06-14 A | 100% |  |  | finish no earlier than 2019-06-15 | R1 | 2088h | 2088h | NR_CLI_RIM-Core | 41 | LG Electronics | Rel-16 | 80 |  |  |
| 2504 | 1012.2 | Perf. part: Cross Link Interference (CLI) handling and Remote Interference Management (RIM) for NR | 261d? | 2018-06-15 A | 2019-06-14 A | 100% |  |  | finish no earlier than 2019-06-15 | R4 | 2088h | 2088h | NR_CLI_RIM-Perf | 41 | LG Electronics | Rel-16 | 80 |  |  |
| 2505 | 1012.3 | UE Conformance Test Aspects - Cross Link Interference (CLI) handling for NR | 710d | 2020-09-17 A | 2023-06-06 | 34% | 468.6d | 718d | finish no earlier than 2023-06-06 | R5 | 5680h |  | NR_CLI-UEConTest | 45 | Vijay Balasubramanian | Rel-16 | 89 | RP-223381 | vijayb[at]qti.qualcomm.com |
| 2506 | 1013 | **DL MIMO efficiency enhancements for LTE** | 391d? | 2018-06-15 A | 2019-12-13 A | 100% |  |  |  | R1 | 9384h | 9384h | LTE_DL_MIMO_EE | 41 | Huawei | Rel-16 | 80 |  |  |
| 2507 | 1013.1 | Core part: DL MIMO efficiency enhancements for LTE | 391d? | 2018-06-15 A | 2019-12-13 A | 100% |  |  | finish no earlier than 2019-12-15 | R1 | 3128h | 3128h | LTE_DL_MIMO_EE-Core | 41 | Huawei | Rel-16 | 80 |  |  |
| 2508 | 1013.2 | Perf. part: DL MIMO efficiency enhancements for LTE | 391d? | 2018-06-15 A | 2019-12-13 A | 100% |  |  | finish no earlier than 2019-12-15 | R4 | 3128h | 3128h | LTE_DL_MIMO_EE-Perf | 41 | Huawei | Rel-16 | 80 |  |  |
| 2509 | 1014 | **Transfer of Iuant interface specifications from 25-series to 37-series** | 68d | 2018-12-13 A | 2019-03-18 A | 100% |  |  |  | R3 | 1088h | 1088h | Iuant_transfer | 42 | Huawei | Rel-16 | 82 |  |  |
| 2510 | 1014.1 | Core part: Transfer of Iuant interface specifications from 25-series to 37-series | 68d | 2018-12-13 A | 2019-03-18 A | 100% |  |  | start no earlier than 2018-12-13 | R3 | 544h | 544h | Iuant_transfer-Core | 42 | Huawei | Rel-16 | 82 |  |  |

Notes:
- 2487: 26/6/19: WID:RP-190665->RP-191285
- 2488: 8/10/19: 0%->100
- 2489: 8/10/19: 0%->100
- 2490: affects: LTE. tested: REL-16 WI LTE_PC2_B31_B72-Core; 25/9/20: 0%->100; 8/10/20: FCD:15/03/2020->09/20
- 2492: basket WI¦16/1/19: WID:RP-181006->RP-182768¦26/3/19: WID:RP-182768->RP-190332; 14/1/20: WID:RP-190332->RP-192453; 26/3/20: WID:RP-192453->RP-200153; 28/7/20: WID:RP-200153->RP-201200; 13/9/21: Compl
- 2493: basket WI¦26/3/19: WID:RP-182768->RP-190332; 28/7/20: 0%->100
- 2494: basket WI¦26/3/19: WID:RP-182768->RP-190332; 28/7/20: 0%->100
- 2495: tested: REL-16 WI LTE_bands_R16_M1_NB1-Core ; 8/4/21: 0%->26; 2/7/21: 26%->80
- 2496: basket WI¦no Perf. part¦16/1/19: WID:RP-181007->RP-182769¦26/3/19: WID:RP-182769->RP-190333; 14/1/20: WID:RP-190333->RP-192454; 26/3/20: WID:RP-192454->RP-200154; 13/9/21: Compl:86%->100% ;
- 2497: basket WI¦no Perf. part¦26/3/19: WID:RP-182769->RP-190333; 28/7/20: WID:RP-200154->RP-201201; 28/7/20: 0%->100
- 2498: tested: REL-16 WI LTE_bands_R16_M2_NB2-Core ; 8/4/21: 0%->33; 2/7/21: 33%->59
- 2500: 14/1/20: 0%->100
- 2501: 26/3/20: 0%->100
- 2502: 16/1/19: WID:RP-181431->RP-182864¦26/3/19: WID:RP-182864->RP-190700; 26/6/19: WID:RP-190700->RP-191546; 8/10/19: WID:RP-191546->RP-191997; 14/1/20: WID:RP-191997->RP-193190
- 2503: 26/3/19: WID:RP-182864->RP-190700; 28/7/20: 0%->100
- 2504: 26/3/19: WID:RP-182864->RP-190700; 28/7/20: 0%->100
- 2505: tested: CLI part of REL-16 WI NR_CLI_RIM-Core ; 7/4/21: WID:RP-201940->RP-210716; 8/4/21: 0%->5; 20/6/22: FCD:17/12/2021->22/12/2022; Compl:5%->19%; Stat Rep: ->RP-221247; Rapporteur: Qualcomm->Vijay Balasubramanian; Rap eMail: ->vijayb@qti.qualcomm.c...; 31/3/23: FCD:31/05/2023->06/06/2023;
- 2506: 16/1/19: WID:RP-181485->RP-182901; 14/1/20: WID:RP-182901->RP-192766
- 2507: 26/3/20: 0%->100
- 2508: 28/7/20: 0%->100
- 2509: administrative WI that transfers REL-8 to REL-15 25.46x specs (formerly created for UMTS, later misused for LTE and recently extended to NR) into 37 series specs affecting UMTS, LTE and NR turning 25.46x specs into pointers to 37 series specs¦no Perf .
- 2510: administrative WI that transfers REL-8 to REL-15 25.46x specs (formerly created for UMTS, later misused for LTE and recently extended to NR) into 37 series specs affecting UMTS, LTE and NR turning 25.46x specs into pointers to 37 series specs¦no Perf .

| ID | WBS | Task | Type | Duration | Start | Finish | Complete | Constraint | Resources | Work | Actual work | Acronym | PCG approved | WI rapporteur name | Release | TSG approved | WI rapporteur e-mail | Status Report | TSG stopped |
| --- | --- | --- | --- | --- | --- | --- | --- | --- | --- | --- | --- | --- | --- | --- | --- | --- | --- | --- | --- |
| 2511 | 1015 | **Direct data forwarding between NG-RAN and E-UTRAN nodes for inter-system mobility** |  | 134d | 2018-12-13 A | 2019-06-18 A | 100% |  | R3 | 2144h | 2144h | Direct_data_fw_NR | 42 | Ericsson | Rel-16 | 82 |  |  |  |
| 2512 | 1015.1 | Core part: Direct data forwarding between NG-RAN and E-UTRAN nodes for inter-system mobility |  | 134d | 2018-12-13 A | 2019-06-18 A | 100% | start no earlier than 2018-12-13 | R3 | 1072h | 1072h | Direct_data_fw_NR-Core | 42 | Ericsson | Rel-16 | 82 |  |  |  |
| 2513 | 1016 | **Even further mobility enhancement in E-UTRAN** |  | 1050d? | 2018-06-15 A | 2022-06-22 A | 100% |  | R2 | 18832h | 18832h | LTE_feMob | 41 | China Telecom | Rel-16 | 80 |  |  |  |
| 2514 | 1016.1 | Core part: Even further mobility enhancement in E-UTRAN |  | 391d? | 2018-06-15 A | 2019-12-13 A | 100% | finish no earlier than 2019-12-15 | R2 | 3128h | 3128h | LTE_feMob-Core | 41 | China Telecom | Rel-16 | 80 |  |  |  |
| 2515 | 1016.2 | Perf. part: Even further mobility enhancement in E-UTRAN |  | 391d? | 2018-06-15 A | 2019-12-13 A | 100% | finish no earlier than 2019-12-15 | R4 | 3128h | 3128h | LTE_feMob-Perf | 41 | China Telecom | Rel-16 | 80 |  |  |  |
| 2516 | 1016.3 | UE Conformance Test Aspects - Even further mobility enhancement in E-UTRAN |  | 523d | 2020-06-22 A | 2022-06-22 A | 100% | finish no earlier than 2022-06-22 | R5 | 4184h | 4184h | LTE_feMob-UEConTest | 45 | Jingzhou Wu, China Telecom | Rel-16 | 88 | wujingzhou@chinatelecom.cn | RP-221293 |  |
| 2517 | 1017 | **410 - 430 MHz E-UTRA FDD Band(s) for LTE PPDR and PMR/PAMR in Europe** |  | 526d | 2018-12-13 A | 2020-12-17 A | 100% |  | R4 | 8928h | 8928h | LTE410_Europe_PPDR | 42 | Nokia | Rel-16 | 82 |  |  |  |
| 2518 | 1017.1 | Core part: 410 - 430 MHz E-UTRA FDD Band(s) for LTE PPDR and PMR/PAMR in Europe |  | 262d | 2018-12-13 A | 2019-12-13 A | 100% | finish no earlier than 2019-12-13 | R4 | 2096h | 2096h | LTE410_Europe_PPDR-Core | 42 | Nokia | Rel-16 | 82 |  |  |  |
| 2519 | 1017.2 | Perf. part: 410 - 430 MHz E-UTRA FDD Band(s) for LTE PPDR and PMR/PAMR in Europe |  | 262d | 2018-12-13 A | 2019-12-13 A | 100% | finish no earlier than 2019-12-13 | R4 | 2096h | 2096h | LTE410_Europe_PPDR-Perf | 42 | Nokia | Rel-16 | 82 |  |  |  |
| 2520 | 1017.3 | UE Conformance Test Aspects - 410-430 MHz E-UTRA FDD Band(s) for LTE PPDR and PMR/PAMR in Europe (Bands 87 and 88) |  | 66d | 2020-09-17 A | 2020-12-17 A | 100% | finish no earlier than 2020-12-17 | R5 | 528h | 528h | LTE410_Europe_PPDR-UEConTest | 45 | Nokia | Rel-16 | 89 |  |  |  |
| 2521 | 1018 | **Support for NavIC Navigation Satellite System for LTE** |  | 127d | 2019-09-19 A | 2020-03-13 A | 100% |  | R2 | 3048h | 3048h | LCS_NAVIC | 43 | Reliance Jio | Rel-16 | 85 |  |  |  |
| 2522 | 1018.1 | Core part: Support for NavIC Navigation Satellite System for LTE |  | 127d | 2019-09-19 A | 2020-03-13 A | 100% | finish no earlier than 2020-03-15 | R2 | 1016h | 1016h | LCS_NAVIC-Core | 43 | Reliance Jio | Rel-16 | 85 |  |  |  |
| 2523 | 1018.2 | Perf. part: Support for NavIC Navigation Satellite System for LTE |  | 127d | 2019-09-19 A | 2020-03-13 A | 100% | finish no earlier than 2020-03-15 | R4 | 1016h | 1016h | LCS_NAVIC-Perf | 43 | Reliance Jio | Rel-16 | 85 |  |  |  |
| 2524 | 1019 | All other Release 16 Features | milestone | 0d? | 2016-06-09 A | 2016-06-09 A | 100% | finish no earlier than 2016-06-09 |  |  |  |  |  |  | Rel-16 |  |  |  |  |
| 2525 | 1020 | 5G Media Streaming stage 3 |  | 334d | 2019-06-06 A | 2020-09-15 A | 100% | finish no earlier than 2020-09-15 | S4 | 2672h | 2672h | 5GMS3 | 43 | Paul Szucs, Sony | Rel-16 | 84 | Paul.Szucs@Sony.com |  |  |
| 2526 | 1021 | User Plane Integrity Protection |  | 10d | 2020-06-12 A | 2020-06-25 A | 100% | finish no earlier than 2020-06-25 | S3 | 80h | 80h | UPIP_SEC | 45 | Tim Evans, Vodafone Group | Rel-16 | 88 | tim.evans1@vodafone.com |  |  |
| 2527 | 1022 | Removal of H.263 and MPEG-4 Visual from 3GPP Services |  | 60d | 2020-06-25 A | 2020-09-16 A | 100% | finish no earlier than 2020-09-16 | S4 | 480h | 480h | RM_H263_MP4V | 45 | Thomas Stockhammer | Rel-16 | 88 | tsto@qti.qualcomm.com |  |  |
| 2528 | 1023 | **Introduction of GSM, UTRA, E-UTRA and NR capability set(s) (CS(s)) to the multi-standard radio (MSR) specifications** |  | 141d | 2019-03-01 A | 2019-09-13 A | 100% |  | R4 | 3384h | 3384h | MSR_GSM_UTRA_LTE_NR | 42 | Ericsson | Rel-16 | 83 |  |  |  |
| 2529 | 1023.1 | Core part: Introduction of GSM, UTRA, E-UTRA and NR CS(s) to the MSR specifications |  | 141d | 2019-03-01 A | 2019-09-13 A | 100% | finish no earlier than 2019-09-15 | R4 | 1128h | 1128h | MSR_GSM_UTRA_LTE_NR-Core | 42 | Ericsson | Rel-16 | 83 |  |  |  |
| 2530 | 1023.2 | Perf. Part: Introduction of GSM, UTRA, E-UTRA and NR CS(s) to the MSR specifications |  | 141d | 2019-03-01 A | 2019-09-13 A | 100% | finish no earlier than 2019-09-15 | R4 | 1128h | 1128h | MSR_GSM_UTRA_LTE_NR-Perf | 42 | Ericsson | Rel-16 | 83 |  |  |  |
| 2531 | 1024 | **Volume Based Charging Aspects for VoLTE** |  | 396d? | 2018-09-06 A | 2020-03-12 A | 100% |  |  | 7472h | 7472h | VBCLTE | 43 | Chen, Ai, China Mobile | Rel-16 | 84 | chenai@chinamobile.com |  |  |
| 2532 | 1024.1 | Stage 2 of VBCLTE |  | 331d? | 2018-09-06 A | 2019-12-12 A | 100% | finish no earlier than 2019-12-12 | S5 | 2648h | 2648h | VBCLTE | 41 | Chen, Ai, China Mobile | Rel-16 | 81 | chenai@chinamobile.com |  |  |
| 2533 | 1024.2 | **CT aspects of VBCLTE** |  | 201d | 2019-06-06 A | 2020-03-12 A | 100% |  | ct | 4824h | 4824h | VBCLTE | 43 | Huang Zhenning (China Mobile) | Rel-16 | 84 | huangzhenning (at) chinamobile (dot) com |  |  |
| 2534 | 1024.2.1 | Stopped - CT1 aspects of VBCLTE |  | 201d | 2019-06-06 A | 2020-03-12 A | 100% | finish no earlier than 2020-03-12 | C1 | 1608h | 1608h | VBCLTE | 43 | Huang Zhenning (China Mobile) | Rel-16 | 84 | huangzhenning (at) chinamobile (dot) com |  | 84 |
| 2535 | 1024.2.2 | CT3 aspects of VBCLTE |  | 201d | 2019-06-06 A | 2020-03-12 A | 100% | finish no earlier than 2020-03-12 | C3 | 1608h | 1608h | VBCLTE | 43 | Huang Zhenning (China Mobile) | Rel-16 | 84 | huangzhenning (at) chinamobile (dot) com |  |  |

Notes:
- 2511: no Perf. part
- 2512: no Perf. part; 26/6/19: 0%->100
- 2513: compare REL-14 WI LTE_eMob¦26/3/19: WID:RP-181475->RP-190272; 26/6/19: WID:RP-190272->RP-190921; 26/3/20: WID:RP-190921->RP-200148
- 2514: compare REL-14 WI LTE_eMob¦26/3/19: WID:RP-181475->RP-190272; 28/7/20: 0%->100
- 2515: 26/3/19: WID:RP-181475->RP-190272; 7/4/21: 0%->100
- 2516: 8/10/20: 0%->5; 8/4/21: 5%->16; 13/9/21: Compl:16%->32%; 13/9/21: CD:Wed 15/12/21->Tue 21/12/21; 13/9/21: Stat Rep: ->RP-211837 ; 20/6/22: Rapporteur: China Telecom->Jingzhou Wu, China Telecom; Rap eMail: ->wujingzhou@chinatelecom.cn;
- 2517: 26/6/19: WID:RP-182898->RP-191287
- 2518: 26/6/19: 0%->100
- 2519: 26/6/19: 0%->100
- 2520: tested: REL-16 WI LTE410_Europe_PPDR-Core ; 6/1/21: 0%->100
- 2521: introduction of Indian GNSS; 14/1/20: WID:RP-192350->RP-192408
- 2522: 26/3/20: 0%->100
- 2523: 26/3/20: 0%->100
- 2524: -
- 2525: 13/9/19: 0%->25; 6/12/19: 25%->50; 6/12/19: FCD:12/12/2019->03/20; 25/3/20: 50%->70; 25/3/20: FCD:12/03/2020->06/20; 10/6/20: 70%->85; 26/6/20: FCD:12/06/2020->09/20; 12/9/20: 85%->100. Moved to Rel-16 / Impacted TSs and TRs: 26.234; 26.247; 26.117; 26.502; 26.503; 26.504; 26.511; 26.512
- 2526: 33.501; 33.401 ; 26/6/20: 0%->100; 25/9/20: WID:SP-200354->SP-200656
- 2527: 26.140; 26.114; 26.244; 26.346; 26.234; 26/6/20: 0%->60; 12/9/20: 60%->100
- 2529: 8/10/19: 0%->100
- 2530: 8/10/19: 0%->100
- 2531: 14/3/19: 0%->50 / Impacted TSs and TRs: 32.251; 32.260; 32.298; 32.299
- 2532: 14/3/19: 0%->50; 13/9/19: 50%->55; 13/9/19: FCD:14/06/2019->12/20; 6/12/19: 55%->100 / Impacted TSs and TRs: 32.251; 32.260; 32.298; 32.299
- 2534: 2/7/20: 0%->100 / Impacted TSs and TRs: 24.229
- 2535: 6/12/19: 0%->100; 26/6/20: WID:CP-191110->CP-201206 / Impacted TSs and TRs: 29.212; 29.213; 29.214

| ID | WBS | Task | Duration | Start | Finish | Complete | Constraint | Resources | Work | Actual work | Acronym | PCG approved | WI rapporteur name | Release | TSG approved | WI rapporteur e-mail |
| --- | --- | --- | --- | --- | --- | --- | --- | --- | --- | --- | --- | --- | --- | --- | --- | --- |
| 2536 | 1025 | **Integrated access and backhaul for NR** | 848d? | 2017-03-15 A | 2020-06-12 A | 100% |  |  | 12904h | 12904h | NR_IAB | 42 | Qualcomm | Rel-16 | 82 |  |
| 2537 | 1025.1 | Study on NR_IAB | 458d? | 2017-03-15 A | 2018-12-14 A | 100% | finish no earlier than 2018-12-15 | R2 | 3664h | 3664h | FS_NR_IAB | 38 | Qualcomm | Rel-16 | 75 |  |
| 2538 | 1025.2 | **Architecture enhancements for the support of Integrated access and backhaul (IAB)** | 126d | 2019-09-19 A | 2020-03-12 A | 100% |  | S2 | 3512h | 3512h | IABARC | 43 | Hong Cheng, Qualcomm Incorporated | Rel-16 | 85 | hongc@qti.qualcomm.com |
| 2539 | 1025.2.1 | Stage 2 of IABARC | 61d | 2019-09-19 A | 2019-12-12 A | 100% | finish no earlier than 2019-12-12 | S2 | 488h | 488h | IABARC | 43 | Hong Cheng, Qualcomm Incorporated | Rel-16 | 85 | hongc@qti.qualcomm.com |
| 2540 | 1025.2.2 | CT4 aspects of IABARC | 126d | 2019-09-19 A | 2020-03-12 A | 100% | finish no earlier than 2020-03-12 | C4 | 1008h | 1008h | IABARC | 43 | Chaponniere, Lena, Qualcomm Incorporated | Rel-16 | 85 | lguellec@qti.qualcomm.com |
| 2541 | 1025.2.3 | CT1 aspects of IABARC | 126d | 2019-09-19 A | 2020-03-12 A | 100% | finish no earlier than 2020-03-12 | C1 | 1008h | 1008h | IABARC | 43 | Chaponniere, Lena, Qualcomm Incorporated | Rel-16 | 85 | lguellec@qti.qualcomm.com |
| 2542 | 1025.3 | Core part: NR_IAB | 262d | 2019-03-07 A | 2020-03-06 A | 100% |  | R2 | 2096h | 2096h | NR_IAB-Core | 42 | Qualcomm | Rel-16 | 82 |  |
| 2543 | 1025.4 | Perf. Part: NR_IAB | 262d | 2019-03-07 A | 2020-03-06 A | 100% |  | R4 | 2096h | 2096h | NR_IAB-Perf | 42 | Qualcomm | Rel-16 | 82 |  |
| 2544 | 1025.5 | Security for IAB | 192d | 2019-09-19 A | 2020-06-12 A | 100% | finish no earlier than 2020-06-12 | S3 | 1536h | 1536h | NR_IAB | 43 | Rajavelsamy Rajadurai, Samsung | Rel-16 | 85 | rajvel{@]samsung.com |
| 2545 | 1026 | User Plane Gateway Function for Inter-PLMN Security | 70d | 2019-12-06 A | 2020-03-12 A | 100% | finish no earlier than 2020-03-12 | S3 | 560h | 560h | UPGF | 44 | Steve Kohalmi, Juniper Networks | Rel-16 | 86 | skohalmi@juniper.net |
| 2546 | 1027 | Enhancements to IMS for new real time communication services | 197d? | 2018-03-15 A | 2018-12-14 A | 100% | finish no earlier than 2018-12-14 | S1 | 1576h | 1576h | enIMS | 40 | China Mobile, Hui Cai | Rel-16 | 79 | caihui at chinamobile dot com |
| 2547 | 1028 | Enhancement of 5G PCC related services | 266d | 2018-12-13 A | 2019-12-19 A | 100% | start no earlier than 2018-12-13 | C3 | 2128h | 2128h | en5GPccSer | 42 | Xiaoyun Zhou, Huawei | Rel-16 | 82 | zhouxiaoyun8@huawei.com |
| 2548 | 1029 | Energy efficiency of 5G | 396d? | 2018-09-06 A | 2020-03-12 A | 100% | finish no earlier than 2020-03-12 | S5 | 3168h | 3168h | EE_5G | 41 | CORNILY, Jean-Michel, ORANGE | Rel-16 | 81 | jeanmichel.cornily@orange.com |
| 2549 | 1030 | Signalling Improvements for Network Efficiency in 5GS | 261d | 2018-12-13 A | 2019-12-12 A | 100% | finish no earlier than 2019-12-12 | C1 | 2088h | 2088h | SINE_5G | 42 | Shu, Lin | Rel-16 | 82 | shulin@huawei.com |
| 2550 | 1031 | New Services and Markets Technology Enablers – Phase 2 | 197d? | 2018-03-15 A | 2018-12-14 A | 100% | finish no earlier than 2018-12-14 | S1 | 1576h | 1576h | SMARTER_Ph2 | 40 | Li, Alice, Vodafone | Rel-16 | 79 | alice.li@vodafone.com |
| 2551 | 1032 | 5G Voice Service Continuity | 59d? | 2017-12-21 A | 2018-03-13 A | 100% | finish no earlier than 2018-03-13 | S1 | 472h | 472h | 5GVSC | 40 | Qun Wei, China Unicom | Rel-16 | 78 | weiqun5@chinaunico.cn |
| 2552 | 1033 | Security Assurance Specification for 5G | 392d? | 2018-03-15 A | 2019-09-13 A | 100% | finish no earlier than 2019-09-13 | S3 | 3136h | 3136h | SCAS_5G | 40 | Marcus Wong, Huawei Technologies | Rel-16 | 79 | mwong@huawei.com |
| 2553 | 1034 | **5GS Transfer of Policies for Background Data Transfer** | 266d? | 2019-03-07 A | 2020-03-12 A | 100% |  |  | 7456h | 7456h | xBDT | 43 |  | Rel-16 | 84 | ta-usui@kddi.com |
| 2554 | 1034.1 | Stage 2 of xBDT | 201d? | 2019-03-07 A | 2019-12-12 A | 100% |  | S2 | 1608h | 1608h | xBDT | 41 |  | Rel-16 | 80 | ta-usui@kddi.com |
| 2555 | 1034.2 | **CT aspects of xBDT** | 201d | 2019-06-06 A | 2020-03-12 A | 100% |  | ct | 5848h | 5848h | xBDT | 43 | Yan Xiaojian, ZTE | Rel-16 | 84 | yan.xiaojian@zte.com.cn |
| 2556 | 1034.2.1 | CT1 aspects of xBDT | 201d | 2019-06-06 A | 2020-03-12 A | 100% | finish no earlier than 2020-03-12 | C1 | 1608h | 1608h | xBDT | 43 | Yan Xiaojian, ZTE | Rel-16 | 84 | yan.xiaojian@zte.com.cn |
| 2557 | 1034.2.2 | CT3 aspects of xBDT | 201d | 2019-06-06 A | 2020-03-12 A | 100% | finish no earlier than 2020-03-12 | C3 | 1608h | 1608h | xBDT | 43 | Yan Xiaojian, ZTE | Rel-16 | 84 | yan.xiaojian@zte.com.cn |
| 2558 | 1034.2.3 | CT4 aspects of xBDT | 128d | 2019-09-17 A | 2020-03-12 A | 100% | start no earlier than 2019-09-17 | C4 | 1024h | 1024h | xBDT | 43 | Yan Xiaojian, ZTE | Rel-16 | 85 | yan.xiaojian@zte.com.cn |
| 2559 | 1035 | Service Interactivity | 590d? | 2017-09-08 A | 2019-12-12 A | 100% | finish no earlier than 2019-12-12 | S4 | 4720h | 4720h | SerInter | 39 | Lo, Charles, Qualcomm Incorporated | Rel-16 | 77 | clo@qti.qualcomm.com |
| 2560 | 1036 | Alternative EVS implementation using updated fixed-point basic operators | 138d? | 2018-06-06 A | 2018-12-14 A | 100% | finish no earlier than 2018-12-14 | S4 | 1104h | 1104h | Alt_FX_EVS | 41 | Pawate, Raj, Cadence Design Systems Inc | Rel-16 | 80 | pawateb@cadence.com |
| 2561 | 1037 | Shared Data Handling on Nudm and Nudr | 138d? | 2018-06-06 A | 2018-12-14 A | 100% | finish no earlier than 2018-12-14 | C4 | 1104h | 1104h | Shared_Data | 41 | Wiehe, Ulrich, Nokia | Rel-16 | 80 | ulrich.wiehe@nokia.com |
| 2562 | 1038 | Usage of CAPIF for xMB API | 197d? | 2018-03-15 A | 2018-12-14 A | 100% | finish no earlier than 2018-12-14 | S4 | 1576h | 1576h | CAPIF4xMB | 40 | Thorsten Lohmar, Ericsson LM | Rel-16 | 79 | Thorsten.lohmar@ericsson.com |
| 2563 | 1039 | Policy delivery to UE for background data transfer | 29d? | 2018-05-08 A | 2018-06-15 A | 100% | start no earlier than 2018-05-08 | S1 | 232h | 232h | PDBDT | 41 | Takatsugu Kito, KDDI | Rel-16 | 80 | ta-kito at kddi dot com |
| 2564 | 1040 | QoS Monitoring | 197d? | 2018-03-15 A | 2018-12-14 A | 100% | finish no earlier than 2018-12-14 | S1 | 1576h | 1576h | QoS_MON | 40 | Amar Deol | Rel-16 | 79 | amar.deol@huawei.com |
| 2565 | 1041 | Inter-RAT Mobility requirements for real time service | 73d? | 2018-06-06 A | 2018-09-14 A | 100% | finish no earlier than 2018-09-14 | S1 | 584h | 584h | MOBRT | 41 | Yang Xu, Oppo | Rel-16 | 80 | xuyang@oppo.com |
| 2566 | 1042 | Management of QoE measurement collection | 659d? | 2017-06-05 A | 2019-12-12 A | 100% | finish no earlier than 2019-12-12 | S5 | 5272h | 5272h | QOED | 39 | Petersen, Robert, Ericsson | Rel-16 | 76 | robert <dot> petersen <at>ericsson<dot>ericsson |
| 2567 | 1043 | Study on network policy management for mobile networks based on NFV scenarios | 269d? | 2017-06-05 A | 2018-06-14 A | 100% | finish no earlier than 2018-06-14 | S5 | 2152h | 2152h | FS_NETPOL | 39 | China Mobile Jinglei Liu | Rel-15 | 76 | liujinglei@chinamobile.com |
| 2568 | 1044 | Network policy management for mobile networks based on NFV scenarios | 331d? | 2018-09-06 A | 2019-12-12 A | 100% | finish no earlier than 2019-12-12 | S5 | 2648h | 2648h | NETPOL | 41 | China Mobile Hao Zhang | Rel-16 | 81 | zhanghao@chinamobile.com |
| 2569 | 1045 | OAM aspects of LTE and WLAN integration | 202d? | 2018-09-06 A | 2019-06-14 A | 100% | finish no earlier than 2019-06-14 | S5 | 1616h | 1616h | OAM_LTE_WLAN | 41 | Yizhi Yao, Intel Corporation | Rel-16 | 81 | yizhi dot yao at intel dot com |
| 2570 | 1046 | Methodology for 5G management specifications | 137d? | 2018-09-06 A | 2019-03-15 A | 100% | finish no earlier than 2019-03-15 | S5 | 1096h | 1096h | METHOGY | 41 | Groenendijk, Jan, Ericsson | Rel-16 | 81 | jan<dot>Groenendijk<at>ericsson<dot>com |
| 2571 | 1047 | Nchf Online and Offline charging services | 201d | 2018-12-13 A | 2019-09-19 A | 100% | start no earlier than 2018-12-13 | S5 | 1608h | 1608h | OFSBI_CH | 42 | Zhu Lei, Huawei | Rel-16 | 82 | Zhulei@huawei.com |
| 2572 | 1048 | Charging Enhancement of 5GC interworking with EPC | 201d | 2018-12-13 A | 2019-09-19 A | 100% | start no earlier than 2018-12-13 | S5 | 1608h | 1608h | 5GIEPC_CH | 42 | Chen Shan, Huawei | Rel-16 | 82 | chenshan@huawei.com |
| 2573 | 1049 | NRM enhancements | 326d | 2018-12-13 A | 2020-03-12 A | 100% | finish no earlier than 2020-03-12 | S5 | 2608h | 2608h | eNRM | 42 | Jing Ping, Nokia | Rel-16 | 82 | jing.ping@nokia-sbell.com |
| 2574 | 1050 | Network Exposure Charging in 5G System Architecture | 266d | 2018-12-13 A | 2019-12-19 A | 100% | start no earlier than 2018-12-13 | S5 | 2128h | 2128h | 5GS_Ph1_NEFCH | 42 | Tornkvist, Robert, Ericsson | Rel-16 | 82 | robert(dot)tornkvist(at)Ericsson(dot)com |
| 2575 | 1051 | Charging AMF in 5G System Architecture Phase 1 | 266d | 2018-12-13 A | 2019-12-19 A | 100% | start no earlier than 2018-12-13 | S5 | 2128h | 2128h | 5GS_Ph1_AMFCH | 42 | Gardella, Maryse, Nokia | Rel-16 | 82 | maryse.gardella@nokia.com |
| 2576 | 1052 | Trace Management in the context of Services Based Management Architecture | 326d | 2018-12-13 A | 2020-03-12 A | 100% | finish no earlier than 2020-03-12 | S5 | 2608h | 2608h | TM_SBMA | 42 | Andrianov, Anatoly, Nokia | Rel-16 | 82 | anatoly.andrianov@nokia.com |
| 2577 | 1053 | Lawful Interception Rel-16 | 652d | 2018-12-13 A | 2021-06-11 A | 100% | finish no earlier than 2021-06-12 | S3LI | 5216h | 5216h | LI16 | 42 | Alex Leadbeater, BT | Rel-16 | 82 | alex.leadbeater@bt.com |

Notes:
- 2536: follow-up WI of REL-16 SI FS_NR_IAB¦26/3/19: WID:RP-182882->RP-190712; 26/6/19: WID:RP-190712->RP-191558; 8/10/19: WID:RP-191558->RP-192188; 14/1/20: WID:RP-192188->RP-193226; 26/3/20: WID:RP-193226->RP-200084; 28/7/20: WID:RP-200084->RP-200840; 25/9/2 / Impacted TSs and TRs: 38.809
- 2537: TR 38.8XX¦30/6/17: 38.874 added;¦19/9/17: WID: RP-170831->RP-171880¦8/1/18: WID: RP-171880->RP-17229027/3/18: Compl:0%->20%¦27/6/18: Compl:20%->50%¦27/6/18: CD:Fri 15/06/18->Sat 15/12/18;¦16/1/19: 50%->100 / Impacted TSs and TRs: 38.874
- 2538: 13/9/19: 0%->33 / Impacted TSs and TRs: 23.501; 23.502; 23.401
- 2539: 13/9/19: 0%->33; 6/12/19: 33%->100 / Impacted TSs and TRs: 23.501; 23.502; 23.401
- 2540: ; 9/12/19: WID:CP-192256->CP-193015; 26/3/20: 0%->100; 2/7/20: WID:CP-193015->CP 201074 / Impacted TSs and TRs: 24.301; 24.501; 23.008; 29.230; 29.272; 29.274; 29.503; 29.504; 29.505; 29.509; 29.518
- 2541: ; 9/12/19: WID:CP-192256->CP-193015; 26/3/20: 0%->100; 2/7/20: 0%->100 / Impacted TSs and TRs: 24.301; 24.501; 23.008; 29.230; 29.272; 29.274; 29.503; 29.504; 29.505; 29.509; 29.518
- 2542: follow-up WI of REL-16 SI FS_NR_IAB¦26/3/19: WID:RP-182882->RP-190712; 8/10/19: WID:RP-190712->RP-192188; 28/7/20: WID:RP-200084->RP-200840; 25/9/20: 0%->100; 25/9/20: 38.175 added;; 25/9/20: 38.809 added; / Impacted TSs and TRs: 38.175; 38.809
- 2543: 26/3/19: WID:RP-182882->RP-190712; 8/10/19: WID:RP-190712->RP-192188; 25/9/20: 38.809 added;; 9/4/21: 38.176-1 and 2 added;; 2/7/21: 0%->100 / Impacted TSs and TRs: 38.809; 38.176-1; 38.176-2
- 2544: ; 6/12/19: 0%->65; 6/12/19: FCD:12/12/2019->03/20; 25/3/20: FCD:12/03/2020->06/20; 26/6/20: 65%->100 / Impacted TSs and TRs: 33.501
- 2545: ; 6/12/19: 0%->90; 25/3/20: 90%->100 / Impacted TSs and TRs: 33.501
- 2546: 7/6/18: 0%->25¦10/9/18: 25%->50¦10/9/18: FCD:09/18->12/18¦4/12/18: 50%->100 / Impacted TSs and TRs: 22.261; 22.468; 22.228; 22.280; 22.281; 22.282; 22.179
- 2547: ¦14/3/19: 0%->10; 31/5/19: 10%->60; 13/9/19: 60%->70; 6/12/19: 70%->90; 26/3/20: 90%->100 / Impacted TSs and TRs: 29.507; 29.512; 29.513; 29.514; 29.551; 29.594; 29.214; 29.519
- 2548: 7/12/18: 0%->20¦14/3/19: 20%->40; 31/5/19: 40%->45; 13/9/19: 45%->70; 12/12/19: WID:SP-180819->SP-191193; 12/12/19: FCD:13/12/2019->03/20; 26/3/20: 70%->95; 28/6/20: 95%->100 / Impacted TSs and TRs: 28.540; 28.541; 28.552; 28.554
- 2549: ¦14/3/19: 0%->50¦18/3/19: FCD:019->12/19¦18/3/19: WID:CP-183085->CP-190142; 31/5/19: 50%->75; 13/9/19: 75%->85; 6/12/19: 85%->95; 26/3/20: 95%->100 / Impacted TSs and TRs: 24.501; 24.301; 24.368; 27.007; 24.008
- 2550: 7/6/18: WID:SP-180138->SP-180313¦7/6/18: 0%->10¦10/9/18: 10%->40¦4/12/18: 40%->100 / Impacted TSs and TRs: 22.261; 22.278
- 2551: 16/3/18: 0%->100 / Impacted TSs and TRs: 22.261
- 2552: 27/3/18: added: 33.514¦33.513¦33.511¦33.512¦33.515 ¦6/8/18: 33.511 to 515 added;¦10/9/18: 0%->10¦2/10/18: WID:SP-180238->SP-180689¦7/12/18: 10%->20¦20/3/19: 20%->60; 31/5/19: 60%->75; 13/9/19: 75%->100 / Impacted TSs and TRs: 33.216; 33.926; 33.515; 33.511; 33.512; 33.513; 33.514; 33.515
- 2553: Impacted TSs and TRs: 23.501; 23.502; 23.503
- 2554: 31/5/19: 0%->100 / Impacted TSs and TRs: 23.501; 23.502; 23.503
- 2555: 17/9/19: WID:CP-191113->CP-192182
- 2556: 13/9/19: 0%->100 / Impacted TSs and TRs: 24.526
- 2557: 13/9/19: 0%->70; 6/12/19: 70%->95; 26/3/20: 95%->100 / Impacted TSs and TRs: 29.519; 29.513; 29.514; 29.122; 29.522; 29.525
- 2558: 26/3/20: 0%->100
- 2559: 15/12/17: 0%->10¦16/3/18: 10%->20¦7/6/18: 20%->40¦7/6/18: FCD:06/18->12/18. Moved from Rel-15¦10/9/18: 40%->50¦7/12/18: 50%->60¦7/3/19: 60%->70¦7/3/19: FCD:12/18->06/19; 31/5/19: FCD:14/06/2019->09/20; 31/5/19: 70%->80; 13/9/19: FCD:12/09/2019->12/20; / Impacted TSs and TRs: 26.346; 26.247; 26.347
- 2560: 6/8/18: 26.452 added;¦10/9/18: 0%->20¦7/12/18: 20%->90¦7/3/19: 90%->100 / Impacted TSs and TRs: 26.441; 26.442; 26.444; 26.445; 26.446; 26.447; 26.449; 26.450; 26.451; 26.952; 26.452
- 2561: 10/9/18: 0%->90¦10/12/18: 90%->100 / Impacted TSs and TRs: 29.503; 29.505; 29.504
- 2562: 7/6/18: 0%->25¦6/8/18: 26.348 added;¦10/9/18: 25%->40¦7/12/18: 40%->100 / Impacted TSs and TRs: 26.346; new; 26.348
- 2563: 10/9/18: 90%->100 / Impacted TSs and TRs: 22.261
- 2564: 7/6/18: 0%->60¦10/9/18: 60%->85¦10/9/18: FCD:06/18->12/18¦4/12/18: 85%->100 / Impacted TSs and TRs: 22.261
- 2565: 10/9/18: 70%->100 / Impacted TSs and TRs: 22.261
- 2566: 30/6/17: 28.309 added;¦30/6/17: 28.308 added;¦30/6/17: 28.307 added;¦30/6/17: 28.406 added;¦11/9/17: 0%->5¦15/12/17: 5%->15¦16/3/18: 15%->25¦7/6/18: FCD:06/18->12/18. 16/6/16: moved from Rel-15¦10/9/18: 25%->30¦7/12/18: 30%->40¦13/12/18: FCD: ; 31/5 / Impacted TSs and TRs: 32.101; 32.103; 6 new TS; 28.309; 28.308; 28.307; 28.406; 28.405; 28.404
- 2567: 30/6/17: 32.871 added;¦11/9/17: 0%->20¦15/12/17: 20%->30¦16/3/18: 30%->35¦7/6/18: 35%->100 / Impacted TSs and TRs: new; 32.871
- 2568: 7/12/18: 0%->10; 13/9/19: 10%->85; 13/9/19: FCD:13/09/2019->12/20; 6/12/19: 85%->100; 12/12/19: WID:SP-180821->SP-191194 / Impacted TSs and TRs: New
- 2569: 7/12/18: 0%->50¦14/3/19: 50%->100 / Impacted TSs and TRs: 32.425; 28.621; 28.622; 28.623; 28.657; 28.658; 28.659
- 2570: 7/12/18: 0%->60¦14/3/19: 60%->85; 13/9/19: 85%->100 / Impacted TSs and TRs: New; 32.156
- 2571: ¦14/3/19: 0%->40; 31/5/19: 40%->70; 13/9/19: 70%->100 / Impacted TSs and TRs: 32.240; 32.255; 32.290; 32.291; 32.298
- 2572: ¦14/3/19: 0%->30; 31/5/19: 30%->60; 13/9/19: 60%->100 / Impacted TSs and TRs: 32.255; 32.291; 32.298
- 2573: ¦14/3/19: 0%->10¦21/3/19: WID:SP-181068 ->SP-190140¦21/3/19: FCD:019->09/19; 31/5/19: 10%->20; 13/9/19: 20%->40; 13/9/19: FCD:12/09/2019->03/20; 20/9/19: WID:SP-190140->SP-190778; 26/3/20: 40%->92; 28/6/20: 92%->98; 13/9/20: 98%->100 / Impacted TSs and TRs: 28.540; 28.541; 28.622 ; 28.623; 28.620
- 2574: ¦14/3/19: 0%->20; 31/5/19: 20%->50; 13/9/19: 50%->60; 6/12/19: 60%->100 / Impacted TSs and TRs: 32.240; 32.254; 32.290; 32.291; 32.298
- 2575: ¦14/3/19: 0%->20; 31/5/19: 20%->50; 13/9/19: 50%->70; 6/12/19: 70%->100 / Impacted TSs and TRs: 32.240; 32.290; 32.291; 32.298; 32.297
- 2576: ; 31/5/19: 0%->10; 13/9/19: FCD:19/06/2019->03/20; 26/3/20: 10%->50; 28/6/20: 50%->100 / Impacted TSs and TRs: 32.421; 32.422; 28.530; 28.532; 28.533; 28.540; 28.541
- 2577: 31/5/19: 0%->15; 13/9/19: 15%->40; 6/12/19: 40%->55; 25/3/20: 55%->60; 25/3/20: FCD:19/12/2019->03/20; 26/6/20: FCD:13/03/2020->09/20; 26/6/20: 60%->85; 12/9/20: 85%->92; 5/12/20: 92%->97; 19/3/21: 97%->99; 19/3/21: FCD:15/09/2020->06/21; 11/6/21: 99%- / Impacted TSs and TRs: 33.107; 33.108; 33.126; 33.127; 33.128

| ID | WBS | Task | Duration | Start | Finish | Complete | Total slack | Constraint | Resources | Work | Actual work | Acronym | PCG approved | WI rapporteur name | WI rapporteur e-mail | Release | TSG approved |
| --- | --- | --- | --- | --- | --- | --- | --- | --- | --- | --- | --- | --- | --- | --- | --- | --- | --- |
| 2578 | 1054 | **IMS Stage-3 IETF Protocol Alignment** | 335d | 2018-12-13 A | 2020-03-25 A | 100% |  |  | C1 | 9552h | 9552h | IMSProtoc16 | 42 | Leis, Peter, Nokia | peter.leis@nokia.com | Rel-16 | 82 |
| 2579 | 1054.1 | CT1 aspects of IMSProtoc16 | 262d | 2018-12-13 A | 2019-12-13 A | 100% |  | finish no earlier than 2019-12-13 | C1 | 2096h | 2096h | IMSProtoc16 | 44 | Leis, Peter, Nokia | peter.leis@nokia.com | Rel-16 | 87 |
| 2580 | 1054.2 | CT3 aspects of IMSProtoc16 | 262d | 2018-12-13 A | 2019-12-13 A | 100% |  | finish no earlier than 2019-12-13 | C3 | 2096h | 2096h | IMSProtoc16 | 44 | Leis, Peter, Nokia | peter.leis@nokia.com | Rel-16 | 87 |
| 2581 | 1054.3 | (IETF) Location Source Parameter for the SIP Geolocation Header Field (draft-ietf-sipcore-locparam) | 335d | 2018-12-13 A | 2020-03-25 A | 100% |  | finish no earlier than 2020-03-25 | C1-IETF | 2680h | 2680h | 5GProtoc16 | 44 | Sedlacek, Ivo, Ericsson | ivo <dot> sedlacek <at> ericsson <dot> com | Rel-16 | 87 |
| 2582 | 1055 | **Stage-3 5GS NAS protocol development** | 335d | 2018-12-13 A | 2020-03-25 A | 100% |  |  | C1 | 8040h | 8040h | 5GProtoc16 | 42 | Sedlacek, Ivo, Ericsson | ivo <dot> sedlacek <at> ericsson <dot> com | Rel-16 | 82 |
| 2583 | 1055.1 | Stage-3 5GS NAS protocol development general aspects | 335d | 2018-12-13 A | 2020-03-25 A | 100% |  | finish no earlier than 2020-03-25 | C1 | 2680h | 2680h | 5GProtoc16 | 42 | Sedlacek, Ivo, Ericsson | ivo <dot> sedlacek <at> ericsson <dot> com | Rel-16 | 82 |
| 2584 | 1055.2 | Stage-3 5GS NAS protocol development for support for non-3GPP accesses | 335d | 2018-12-13 A | 2020-03-25 A | 100% |  | finish no earlier than 2020-03-25 | C1 | 2680h | 2680h | 5GProtoc16-non3GPP | 42 | Sedlacek, Ivo, Ericsson | ivo <dot> sedlacek <at> ericsson <dot> com | Rel-16 | 82 |
| 2585 | 1056 | **Stage-3 SAE Protocol Development for Rel16** | 266d | 2018-12-13 A | 2019-12-19 A | 100% |  |  | C1 | 8512h | 8512h | SAES16 | 42 | Aghili, Behrouz, InterDigital Communications | behrouz.aghili@interdigital.com | Rel-16 | 82 |
| 2586 | 1056.1 | Stage-3 SAE Protocol Development for Rel16 general aspects | 266d | 2018-12-13 A | 2019-12-19 A | 100% |  | start no earlier than 2018-12-13 | C1 | 2128h | 2128h | SAES16 | 42 | Aghili, Behrouz, InterDigital Communications | behrouz.aghili@interdigital.com | Rel-16 | 82 |
| 2587 | 1056.2 | Stage-3 SAE Protocol Development for Rel16 for CS Fallback in EPS | 266d | 2018-12-13 A | 2019-12-19 A | 100% |  | start no earlier than 2018-12-13 | C1 | 2128h | 2128h | SAES16-CSFB | 42 | Aghili, Behrouz, InterDigital Communications | behrouz.aghili@interdigital.com | Rel-16 | 82 |
| 2588 | 1056.3 | Stage-3 SAE Protocol Development Rel16 for support for non-3GPP accesses | 266d | 2018-12-13 A | 2019-12-19 A | 100% |  | start no earlier than 2018-12-13 | C1 | 2128h | 2128h | SAES16-non3GPP | 42 | Aghili, Behrouz, InterDigital Communications | behrouz.aghili@interdigital.com | Rel-16 | 82 |
| 2589 | 1057 | S6b Optional for ePDG connected to 5GS | 21d | 2019-05-09 A | 2019-06-06 A | 100% |  | start no earlier than 2019-05-09 | S2 | 168h | 168h | 5GS_S6b_Optional | 43 | Irfan Ali, Cisco | irfaali at cisco dot com | Rel-16 | 84 |
| 2590 | 1058 | **Service Based Interface Protocol Improvements** | 201d | 2019-06-06 A | 2020-03-12 A | 100% |  |  | ct | 4824h | 4824h | SBIProtoc16 | 43 | Yue Song, China Mobile | songyue (at) chinamobile (dot) com | Rel-16 | 84 |
| 2591 | 1058.1 | CT3 aspects of SBIProtoc16 | 201d | 2019-06-06 A | 2020-03-12 A | 100% |  | finish no earlier than 2020-03-12 | C3 | 1608h | 1608h | SBIProtoc16 | 43 | Yue Song, China Mobile | songyue (at) chinamobile (dot) com | Rel-16 | 84 |
| 2592 | 1058.2 | CT4 aspects of SBIProtoc16 | 201d | 2019-06-06 A | 2020-03-12 A | 100% |  | finish no earlier than 2020-03-12 | C4 | 1608h | 1608h | SBIProtoc16 | 43 | Yue Song, China Mobile | songyue (at) chinamobile (dot) com | Rel-16 | 84 |
| 2593 | 1059 | Withdrawal of TS 24.323 from Rel-11, Rel-12, Rel-13 | 201d | 2019-06-06 A | 2020-03-12 A | 100% |  | finish no earlier than 2020-03-12 | C1 | 1608h | 1608h | ISAT-MO-WITHDRAW | 43 | Dawes, Peter, Vodafone | peter(dot)dawes(at)vodafone(dot)com | Rel-16 | 84 |
| 2594 | 1060 | Lawful Interception Report Rel-16 | 136d | 2019-06-06 | 2019-12-12 |  | 1627d | finish no earlier than 2019-12-12 | S3LI | 1088h |  | LIR16 | 43 | Nag Rao, Nokia | nagaraja.rao@nokia.com | Rel-16 | 84 |
| 2595 | 1061 | RTCP Verification for Real-Time Services | 130d | 2019-09-13 A | 2020-03-12 A | 100% |  | start no earlier than 2019-09-13 | S4 | 1040h | 1040h | RTCPVer | 43 | Burman, Bo, Ericsson LM, | bo.burman@ericsson.com | Rel-16 | 85 |
| 2596 | 1062 | Network Slice Performance and Analytics Charging in 5G System | 126d | 2019-09-19 A | 2020-03-12 A | 100% |  | finish no earlier than 2020-03-12 | S5 | 1008h | 1008h | 5GS_NSPACH | 43 | Chen Shan, Huawei | chenshan@huawei.com | Rel-16 | 85 |
| 2597 | 1063 | Closed loop SLS Assurance | 126d | 2019-09-19 A | 2020-03-12 A | 100% |  | finish no earlier than 2020-03-12 | S5 | 1008h | 1008h | COSLA | 43 | Groenendijk, Jan, Ericsson | jan.groenendijk@ericsson.com | Rel-16 | 85 |
| 2598 | 1064 | Streaming trace reporting | 126d | 2019-09-19 A | 2020-03-12 A | 100% |  | finish no earlier than 2020-03-12 | S5 | 1008h | 1008h | OAM_RTT | 43 | Andrianov, Anatoly, Nokia | anatoly.andrianov@nokia.com | Rel-16 | 85 |
| 2599 | 1065 | Enhancement of 3GPP management system for multiple tenant environment support | 126d | 2019-09-19 A | 2020-03-12 A | 100% |  | finish no earlier than 2020-03-12 | S5 | 1008h | 1008h | MEMTANE | 43 | Zhu, Lei, Huawei | lei.zhu@huawei.com | Rel-16 | 85 |
| 2600 | 1066 | Network Slice Management Charging in 5G System | 126d | 2019-09-19 A | 2020-03-12 A | 100% |  | finish no earlier than 2020-03-12 | S5 | 1008h | 1008h | 5GS_NSMCH | 43 | Gardella, Maryse, Nokia | maryse.gardella@nokia.com | Rel-16 | 85 |
| 2601 | 1067 | Management Aspects of 5G Service-Level Agreement | 126d | 2019-09-19 A | 2020-03-12 A | 100% |  | finish no earlier than 2020-03-12 | S5 | 1008h | 1008h | MA5SLA | 43 | Hu, Yushuang, CMCC | huyushuang@chinamobile.com | Rel-16 | 85 |

Notes:
- 2578: ¦14/3/19: 0%->25; 31/5/19: 25%->45; 13/9/19: 45%->65; 6/12/19: 65%->90; 26/3/20: 90%->100; 30/6/20: 99%->100 / Impacted TSs and TRs: 23.218; 24.229; 24.930; 29.163; 29.165; 29.292
- 2579: ¦14/3/19: 0%->25; 31/5/19: 25%->45; 13/9/19: 45%->65; 6/12/19: 65%->90; 26/3/20: 90%->100; 23/4/20: FCD:19/12/2019-> / Impacted TSs and TRs: 23.218; 24.229; 24.930; 29.163; 29.165; 29.292
- 2580: ¦14/3/19: 0%->25; 31/5/19: 25%->45; 13/9/19: 45%->65; 6/12/19: 65%->90; 26/3/20: 90%->100; 23/4/20: FCD:19/12/2019-> / Impacted TSs and TRs: 23.218; 24.229; 24.930; 29.163; 29.165; 29.292
- 2581: ¦14/3/19: 0%->25; 31/5/19: 25%->50; 13/9/19: 50%->65; 6/12/19: 65%->90; 25/3/20: FCD:19/12/2019->03/20; 26/3/20: 90%->98; 30/6/20: 90%->100; 9/4/21: RFC 8787 added; / Impacted TSs and TRs: 23.040; 23.041; 23.122; 24.007; 24.008; 24.011; 24.229; 24.301; 24.302; 24.305; 24.368; 24.501; 24.502; 24.526; 27.007 ; RFC 8787
- 2582: ; 25/3/20: WID:CP-183087->CP-200146 / Impacted TSs and TRs: 23.040; 23.041; 23.122; 24.007; 24.008; 24.011; 24.229; 24.301; 24.302; 24.305; 24.368; 24.501; 24.502; 24.526; 27.007
- 2583: ¦14/3/19: 0%->25; 31/5/19: 25%->50; 13/9/19: 50%->65; 6/12/19: 65%->90; 25/3/20: FCD:19/12/2019->03/20; 26/3/20: 90%->98; 26/6/20: 98%->100 / Impacted TSs and TRs: 23.040; 23.041; 23.122; 24.007; 24.008; 24.011; 24.229; 24.301; 24.302; 24.305; 24.368; 24.501; 24.502; 24.526; 27.007
- 2584: ¦14/3/19: 0%->25; 31/5/19: 25%->50; 25/3/20: FCD:19/12/2019->03/20; 30/6/20: 50%->100 / Impacted TSs and TRs: 23.040; 23.041; 23.122; 24.007; 24.008; 24.011; 24.229; 24.301; 24.302; 24.305; 24.368; 24.501; 24.502; 24.526; 27.007
- 2585: Impacted TSs and TRs: 23.122; 24.008; 24.167; 24.229; 24.301; 24.302; 24.303; 24.304; 24.305; 24.312; 29.018; 29.118; 24.368
- 2586: 14/3/19: 0%->25; 31/5/19: 25%->50; 13/9/19: 50%->65; 6/12/19: 65%->90; 26/3/20: 90%->100 / Impacted TSs and TRs: 23.122; 24.008; 24.167; 24.229; 24.301; 24.302; 24.303; 24.304; 24.305; 24.312; 29.018; 29.118; 24.368
- 2587: 14/3/19: 0%->25; 31/5/19: 25%->50; 30/6/20: 50%->100 / Impacted TSs and TRs: 23.122; 24.008; 24.167; 24.229; 24.301; 24.302; 24.303; 24.304; 24.305; 24.312; 29.018; 29.118; 24.368
- 2588: 14/3/19: 0%->25; 31/5/19: 25%->50; 30/6/20: 50%->100 / Impacted TSs and TRs: 23.122; 24.008; 24.167; 24.229; 24.301; 24.302; 24.303; 24.304; 24.305; 24.312; 29.018; 29.118; 24.368
- 2589: 6/6/19: 0%->100 / Impacted TSs and TRs: 23.501; 23.502
- 2591: 13/9/19: 0%->25; 6/12/19: 25%->75; 26/3/20: 75%->100 / Impacted TSs and TRs: 29.507; 29.508; 29.512; 29.514; 29.519; 29.520; 29.521; 29.522; 29.523; 29.525; 29.551; 29.554
- 2592: 31/5/19: 0%->10; 6/12/19: 10%->90; 26/3/20: 90%->95; 26/6/20: 95%->100 / Impacted TSs and TRs: 29.500; 29.501; 29.502; 29.503; 29.504; 29.505; 29.509; 29.510; 29.511; 29.531; 29.540; 29.518; 29.571; 29.572; 29.573
- 2593: ; 13/9/19: 0%->100 / Impacted TSs and TRs: 24.323
- 2594: Impacted TSs and TRs: New
- 2595: ; 8/10/19: 26.139 added;; 6/12/19: 0%->60; 25/3/20: 60%->100 / Impacted TSs and TRs: 26.114; 24.380; 24.581; 26.281; New ; 26.139
- 2596: 8/10/19: 28.201 added;; 6/12/19: 0%->15; 26/3/20: 15%->30; 28/6/20: 30%->60; 13/9/20: 60%->100 / Impacted TSs and TRs: 32.240; 32.290; 32.291; 32.298; 32.297 ; 28.201
- 2597: ; 8/10/19: 28.536 added;; 26/3/20: 0%->55; 28/6/20: 55%->100 / Impacted TSs and TRs: 28.533; 28.540; 28.541; 28.530; 28.531; 28.545; 28.546; 28.550; 28.552; 28.553 ; 28.536; 28.535
- 2598: ; 26/3/20: 0%->25; 28/6/20: 25%->100 / Impacted TSs and TRs: 32.421; 32.422; 32.423; 28.532; 28.533
- 2599: ; 26/3/20: 0%->35; 28/6/20: 35%->100 / Impacted TSs and TRs: 28.531; 28.532; 28.533; 28.541; 28.552; 28.554
- 2600: ; 8/10/19: 28.202 added;; 6/12/19: 0%->5; 28/6/20: 5%->50; 13/9/20: 50%->100 / Impacted TSs and TRs: 32.240; 32.290; 32.291; 32.298; 32.297 ; 28.202
- 2601: ; 25/3/20: WID:SP-190789->SP-200185; 26/3/20: 0%->100 / Impacted TSs and TRs: 28.540; 28.541

| ID | WBS | Task | Type | Duration | Start | Finish | Complete | Remaining | Total slack | Constraint | Resources | Work | Actual work | Acronym | PCG approved | WI rapporteur name | WI rapporteur e-mail | Release | TSG approved | Impacted TSs and TRs | Status Report | TSG stopped |
| --- | --- | --- | --- | --- | --- | --- | --- | --- | --- | --- | --- | --- | --- | --- | --- | --- | --- | --- | --- | --- | --- | --- |
| 2602 | 1068 | **Load and Overload Control of 5GC Service Based Interfaces** |  | 462d? | 2018-06-06 A | 2020-03-12 A | 100% |  |  |  |  | 4160h | 4160h | LOLC | 43 | Giorgi Gulbani (Huawei) | giorgi.gulbani@huawei.com | Rel-16 | 85 |  |  |  |
| 2603 | 1068.1 | Study on Load and Overload Control of 5GC Service Based Interfaces |  | 268d? | 2018-06-06 A | 2019-06-14 A | 100% |  |  | finish no earlier than 2019-06-14 | C4 | 2144h | 2144h | FS_LOLC | 41 | Sridhar Bhaskaran (Huawei) | sridhar.bhaskaran@huawei.com | Rel-16 | 80 | New; 22.943 |  |  |
| 2604 | 1068.2 | Deleted: C3 aspects of LOLC (TBD) |  | 126d | 2019-09-19 A | 2020-03-12 A | 100% |  |  | finish no earlier than 2020-03-12 | C3 | 1008h | 1008h | LOLC | 43 | Giorgi Gulbani (Huawei) | giorgi.gulbani@huawei.com | Rel-16 | 85 | TBD |  |  |
| 2605 | 1068.3 | C4 aspects of LOLC |  | 126d | 2019-09-19 A | 2020-03-12 A | 100% |  |  | finish no earlier than 2020-03-12 | C4 | 1008h | 1008h | LOLC | 43 | Giorgi Gulbani (Huawei) | giorgi.gulbani@huawei.com | Rel-16 | 85 | 29.500; 29.510 |  |  |
| 2606 | 1069 | **5GS Enhanced support of Over the air (OTA) mechanism for UICC configuration parameter update** |  | 126d | 2019-09-19 A | 2020-03-12 A | 100% |  |  |  | C4 | 3024h | 3024h | 5GS_OTAF | 43 | Wiehe, Ulrich, Nokia | Ulrich.Wiehe@nokia.com | Rel-16 | 85 | 23.122; 29.503 ; 29.510 |  |  |
| 2607 | 1069.1 | C1 aspects of 5GS_OTAF |  | 126d | 2019-09-19 A | 2020-03-12 A | 100% |  |  | finish no earlier than 2020-03-12 | C1 | 1008h | 1008h | 5GS_OTAF | 43 | Wiehe, Ulrich, Nokia | Ulrich.Wiehe@nokia.com | Rel-16 | 85 | 23.122; 29.503 ; 29.510 |  |  |
| 2608 | 1069.2 | C4 aspects of 5GS_OTAF |  | 126d | 2019-09-19 A | 2020-03-12 A | 100% |  |  | finish no earlier than 2020-03-12 | C4 | 1008h | 1008h | 5GS_OTAF | 43 | Wiehe, Ulrich, Nokia | Ulrich.Wiehe@nokia.com | Rel-16 | 85 | 23.122; 29.503 ; 29.510 |  |  |
| 2609 | 1070 | Integration of ONAP and 3GPP 5G management framework |  | 265.88d | 2019-03-07 A | 2020-03-12 A | 100% |  |  | finish no earlier than 2020-03-12 | S5 | 2127h | 2127h | ONAP3GPP | 42 | SMITH David K., AT&T | DS9930@att.com | Rel-16 | 83 | 28.540; 28.622; 28.623; 28.532 |  |  |
| 2610 | 1071 | Support of Hybrid DASH/HLS over eMBMS |  | 70d | 2019-12-06 A | 2020-03-12 A | 100% |  |  | start no earlier than 2019-12-06 | S4 | 560h | 560h | DAHOE | 44 | Thienot, Cédric, Enensys | cedric.thienot@enensys.com | Rel-16 | 86 | 26.346; 26.347; 26.348 |  |  |
| 2611 | 1072 | 3GPP profiles for cryptographic algorithms and security protocols |  | 70d | 2019-12-06 A | 2020-03-12 A | 100% |  |  | finish no earlier than 2020-03-12 | S3 | 560h | 560h | CryptPr | 44 | Christine Jost, Ericsson | christine.jost@ericsson.com | Rel-16 | 86 | 33.210; 33.310; 33.501 |  |  |
| 2612 | 1073 | CHF-controlled quota management |  | 70d | 2019-12-06 A | 2020-03-12 A | 100% |  |  | finish no earlier than 2020-03-12 | S5 | 560h | 560h | CHFCQM | 44 | Lagha, Naceur, Amdocs | nlagha@amdocs.com | Rel-16 | 86 | 32.255; 32.290; 32.291 |  |  |
| 2613 | 1074 | Management of MDT in 5G |  | 70d | 2019-12-06 A | 2020-03-12 A | 100% |  |  | finish no earlier than 2020-03-12 | S5 | 560h | 560h | 5GMDT | 44 | Ayani, Zhulia, Ericsson | zhulia.Ayani@ericsson.com | Rel-16 | 86 | 32.421; 32.422; 32.423; 28.532; 28.533 |  |  |
| 2614 | 1075 | 5G management capabilities |  | 70d | 2019-12-06 A | 2020-03-12 A | 100% |  |  | finish no earlier than 2020-03-12 | S5 | 560h | 560h | 5GMNC | 44 | CORNILY, Jean-Michel, ORANGE | jeanmichel.cornily@orange.com | Rel-16 | 86 | 28.532 |  |  |
| 2615 | 1076 | Nudsf Service Based Interface |  | 70d | 2019-12-06 A | 2020-03-12 A | 100% |  |  | finish no earlier than 2020-03-12 | C4 | 560h | 560h | NUDSF | 44 | Askerup, Anders, Hewlett Packard Enterprise, | Anders.Askerup@hpe.com. | Rel-16 | 86 | 29.510; 29.500 |  |  |
| 2616 | 1077 | Study on Nudsf Service Based Interface |  | 136d | 2019-06-06 A | 2019-12-12 A | 100% |  |  | finish no earlier than 2019-12-12 | C4 | 1088h | 1088h | FS_NUDSF | 43 | Askerup, Anders, Hewlett Packard Enterprise | Anders.Askerup@hpe.com | Rel-16 | 84 | 29.808 |  |  |
| 2617 | 1078 | Nsoraf Service Based Interface |  | 70d | 2019-12-06 A | 2020-03-12 A | 100% |  |  | finish no earlier than 2020-03-12 | C4 | 560h | 560h | NSORAF | 44 | EL MOATAMID, Abdessamad, Orange | abdessamad.elmoatamid@orange.com. | Rel-16 | 86 | 29.503; 29.510 |  |  |
| 2618 | 1079 | Video enhancement of IMS CAT/CRS/announcement services |  | 70d | 2019-12-06 A | 2020-03-12 A | 100% |  |  | finish no earlier than 2020-03-12 | C1 | 560h | 560h | eIMSVideo | 44 | Hongxia Hao, Huawei | haohongxia@huawei.com | Rel-16 | 86 | 24.182; 24.183; 24.628 |  |  |
| 2619 | 1080 | Ambient noise test methodology for evaluation of acoustic UE performance |  | 28d | 2020-02-17 A | 2020-03-25 A | 100% |  |  | start no earlier than 2020-02-17 | S4 | 224h | 224h | ANTeM | 44 | Jan Reimes, HEAD acoustics GmbH, | jan.reimes@head-acoustics.de | Rel-16 | 87 | 26.132 |  |  |
| 2620 | 1081 | UE Conformance Test Aspects - B1C Signal in BDS Positioning System Support for LTE and NR |  | 255d | 2020-09-17 A | 2021-09-08 A | 100% |  |  | finish no earlier than 2021-09-08 | R5 | 2040h | 2040h | B1C_BDS_pos_UEConTest | 45 | CATT |  | Rel-16 | 89 |  |  |  |
| 2621 | 1082 | UE Conformance Test Aspects - Support of eCall over IMS for NR |  | 517d | 2021-03-12 A | 2023-03-03 A | 100% |  |  | finish no earlier than 2023-03-03 | R5 | 4136h | 4136h | NR_EIEI-UEConTest | 46 | Bharadwaj Kumar Cheruvu, Qualcomm | bcheruvu[at]qti.qualcomm.com | Rel-16 | 91 |  | RP-230094 |  |
| 2622 | 1083 | UE Conformance Test Aspects Release 16 |  | 332d | 2022-06-03 A | 2023-09-09 A | 100% |  |  | finish no earlier than 2023-09-09 | C6 | 2656h | 2656h | UEConTest_R16 | 49 | COLLET, Hervé, Thales | herve.collet@thalesgroup.com | Rel-16 | 96 | 31.121; 31.124 |  |  |
| 2623 | 1084 | **(Small) Technical Enhancements and Improvements for Rel-16** |  | 732d? | 2017-09-11 A | 2020-06-30 |  | 732d? | 1484d |  |  | 912h |  | TEI16 | 41 |  |  | Rel-16 | 77 |  |  |  |
| 2624 | 1084.1 | (IETF) The Transport Layer Security (TLS) Protocol Version 1.3 (RFC 8446) | milestone | 0d? | 2017-09-11 A | 2017-09-11 A | 100% |  |  | finish no earlier than 2018-12-14 | S3-IETF |  |  | TEI16 | 41 |  |  | Rel-16 | 80 |  |  |  |
| 2625 | 1084.2 | (Small) Test Technical Enhancements and Improvements for Rel-16 |  | 114d? | 2020-01-23 | 2020-06-30 |  |  | 1484d | finish no earlier than 2020-06-30 | R5 | 912h |  | TEI16_Test | 41 |  |  | Rel-16 | 86 |  |  |  |
| 2626 | 1085 | Release 16 Studies with no corresponding Feature | milestone | 0d? | 2016-03-15 A | 2016-03-15 A | 100% |  |  | start no earlier than 2016-03-15 |  |  |  |  |  |  |  | Rel-16 |  |  |  |  |
| 2627 | 1086 | Release 16 Studies on 5G/5GS/5GC/NR | milestone | 0d? | 2016-06-09 A | 2016-06-09 A | 100% |  |  | finish no earlier than 2016-06-09 |  |  |  |  |  |  |  | Rel-16 |  |  |  |  |
| 2628 | 1087 | Stopped - Study on system architecture for next generation real time communication services |  | 202d? | 2018-06-06 A | 2019-03-14 A | 100% |  |  | finish no earlier than 2019-03-14 | S2 | 1616h | 1616h | FS_NG_RTC | 41 | Yi Jiang | jiangyi at chinamobile dot com | Rel-16 | 80 | New |  | 84 |
| 2629 | 1088 | Study on security aspects of single radio voice continuity from 5G to UTRAN |  | 262d? | 2018-03-15 A | 2019-03-15 A | 100% |  |  | finish no earlier than 2019-03-15 | S3 | 2096h | 2096h | FS_5G_UTRAN_SEC | 40 | Feng Gao, China Unicom | gaofeng149@chinaunicom.cn | Rel-16 | 79 | 33.856 |  |  |
| 2630 | 1089 | Study on supporting 256-bit algorithms for 5G |  | 196d? | 2017-12-15 A | 2018-09-14 A | 100% |  |  | finish no earlier than 2018-09-14 | S3 | 1568h | 1568h | FS_256_Algo | 40 | Evans, Tim, Vodafone Group | tim.evans1@vodafone.com | Rel-16 | 78 | new |  |  |
| 2631 | 1090 | Study on User Plane Protocol in 5GC |  | 391d? | 2017-12-15 A | 2019-06-14 A | 100% |  |  | finish no earlier than 2019-06-14 | C4 | 3128h | 3128h | FS_UPPS | 40 | Satoru Matsushima, SoftBank Corp | satoru.matsushima@g.softbank.co.jp | Rel-16 | 78 | 29.892 |  |  |
| 2632 | 1091 | Stopped - Study on Application Awareness Interworking between LTE and NR |  | 261d? | 2018-03-15 A | 2019-03-14 A | 100% |  |  | finish no earlier than 2019-03-14 | S2 | 2088h | 2088h | FS_AAI_LTE_NR | 40 | Biao Long, China Telecom | longb.gd@chinatelecom.cn | Rel-16 | 79 | new; 23.727 |  | 84 |
| 2633 | 1092 | Study on NR beyond 52.6 GHz |  | 66d? | 2018-06-15 A | 2018-09-14 A | 100% |  |  | finish no earlier than 2018-09-14 | RP | 528h | 528h | FS_NR_beyond_52GHz | 41 | Intel |  | Rel-16 | 80 | 38.8xx |  |  |
| 2634 | 1093 | Study on remote interference management for NR |  | 131d? | 2018-06-15 A | 2018-12-14 A | 100% |  |  | finish no earlier than 2018-12-15 | R1 | 1048h | 1048h | FS_NR_RIM | 41 | CMCC |  | Rel-16 | 80 |  |  |  |
| 2635 | 1094 | Study on RAN-centric data collection and utilization for LTE and NR |  | 261d? | 2018-06-01 A | 2019-05-31 A | 100% |  |  | finish no earlier than 2019-06-01 | R3 | 2088h | 2088h | FS_LTE_NR_data_collect | 41 | CMCC |  | Rel-16 | 80 |  |  |  |
| 2636 | 1095 | Study on radiated metrics and test methodology for the verification of multi-antenna reception performance of NR UEs |  | 391d? | 2018-06-15 A | 2019-12-13 A | 100% |  |  | finish no earlier than 2019-12-15 | R4 | 3128h | 3128h | FS_NR_MIMO_OTA_test | 41 | CAICT |  | Rel-16 | 80 |  |  |  |
| 2637 | 1096 | Study on evaluation for 2 RX exception in Rel-15 vehicle mounted UE for NR |  | 141d? | 2018-06-01 A | 2018-12-14 A | 100% |  |  | finish no earlier than 2018-12-15 | R4 | 1128h | 1128h | FS_NR_2RX_vehUE | 41 | Samsung |  | Rel-16 | 80 |  |  |  |
| 2638 | 1097 | Study of test methods for New Radio |  | 393d? | 2017-03-15 A | 2018-09-14 A | 100% |  |  | finish no earlier than 2018-09-15 | R4 | 3144h | 3144h | FS_NR_test_methods | 38 | Intel |  | Rel-16 | 75 | 38.810 |  |  |
| 2639 | 1098 | Study on Non-Orthogonal Multiple Access (NOMA) for NR |  | 458d? | 2017-03-15 A | 2018-12-14 A | 100% |  |  | finish no earlier than 2018-12-15 | R1 | 3664h | 3664h | FS_NR_NOMA | 38 | ZTE |  | Rel-16 | 75 | 32.812 |  |  |
| 2640 | 1099 | Stopped - Study of KDF negotiation for 5G System Security |  | 202d? | 2018-09-06 A | 2019-06-14 A | 100% |  |  | finish no earlier than 2019-06-14 | S3 | 1616h | 1616h | FS_5GS_KDF | 41 | Ahmad Muhanna | ahmad.muhanna@huawei.com | Rel-16 | 81 | New |  | 84 |
| 2641 | 1100 | Study on Long Term Key Update Procedures |  | 400d? | 2017-06-05 A | 2018-12-14 A | 100% |  |  | finish no earlier than 2018-12-14 | S3 | 3200h | 3200h | FS_LTKUP | 39 | Evans, Tim, Vodafone | tim.evans1@vodafone.com | Rel-16 | 76 | Internal TR |  |  |
| 2642 | 1101 | Study on eXtended Reality (XR) in 5G |  | 378d? | 2018-10-02 A | 2020-03-12 A | 100% |  |  | finish no earlier than 2020-03-12 | S4 | 3024h | 3024h | FS_5GXR | 41 | Thomas Stockhammer, Qualcomm Incorporated | tsto@qti.qualcomm.com | Rel-16 | 81 | 26.9xx; 26.998 |  |  |
| 2643 | 1102 | Study on 7 - 24 GHz frequency range for NR |  | 262d | 2018-12-13 A | 2019-12-13 A | 100% |  |  | start no earlier than 2018-12-13 | R4 | 2096h | 2096h | FS_7to24GHz_NR | 42 | Huawei |  | Rel-16 | 82 |  |  |  |
| 2644 | 1103 | Study on UEs Supporting Handset Mode with Non-Traditional Earpieces |  | 130.88d | 2019-03-07 A | 2019-09-05 A | 100% |  |  |  | S4 | 1047h | 1047h | FS_HaNTE | 42 | Schevciw, Andre, Qualcomm Incorporated | aschevci@qti.qualcomm.com | Rel-16 | 83 | New |  |  |
| 2645 | 1104 | Study on enhancement for disaggregated gNB architecture |  | 206d | 2019-03-01 A | 2019-12-13 A | 100% |  |  | finish no earlier than 2019-12-15 | R3 | 1648h | 1648h | FS_enh_disagg_gNB | 42 | China Telecom |  | Rel-16 | 83 | 38.823 |  |  |
| 2646 | 1105 | Study on 5G NR UE Application Layer Data Throughput Performance |  | 583d | 2019-06-17 A | 2021-09-08 A | 100% |  |  | finish no earlier than 2021-09-08 | R5 | 4664h | 4664h | FS_UE_5GNR_App_Data_Perf | 43 | Qualcomm |  | Rel-16 | 84 | 37.901-5 |  |  |
| 2647 | 1106 | Release 16 other Studies | milestone | 0d? | 2016-06-09 A | 2016-06-09 A | 100% |  |  | finish no earlier than 2016-06-09 |  |  |  |  |  |  |  | Rel-16 |  |  |  |  |
| 2648 | 1107 | Study on using Satellite Access in 5G |  | 201d? | 2017-09-08 A | 2018-06-15 A | 100% |  |  | finish no earlier than 2018-06-15 | S1 | 1608h | 1608h | FS_5GSAT | 39 | MICHEL, Cyril | cyril.michel@thalesaleniaspace.com | Rel-16 | 77 | New; 22.822 |  |  |
| 2649 | 1108 | Study on enhancements to IMS for new real time communication services |  | 71d? | 2017-09-08 A | 2017-12-15 A | 100% |  |  | start no earlier than 2017-09-08 | S1 | 568h | 568h | FS_enIMS | 39 | China Mobile, Hui Cai | caihui at chinamobile dot com | Rel-16 | 77 | New; 22.823; 26.998 |  |  |
| 2650 | 1109 | Stopped - Study on protocol enhancement for real time communication |  | 528d? | 2018-06-06 A | 2020-06-12 A | 100% |  |  | finish no earlier than 2020-06-12 | S5 | 4224h | 4224h | FS_PROTIMP | 41 | Olaf Pollakowski, Nokia | olaf.pollakowski@nokia.com | Rel-16 | 80 | New; 28.823 |  | 84 |
| 2651 | 1110 | Study on integration of ONAP and 3GPP configuration management services for 5G networks |  | 202d? | 2018-06-06 A | 2019-03-14 A | 100% |  |  | finish no earlier than 2019-03-14 | S5 | 1616h | 1616h | FS_ONAPCINT | 41 | Li Gang, Ericsson | gang.g.li@ericsson.com | Rel-16 | 80 | New; 28.890 |  |  |
| 2652 | 1111 | Study on integration of ONAP DCAE and 3GPP management architecture |  | 326d? | 2017-12-15 A | 2019-03-15 A | 100% |  |  | finish no earlier than 2019-03-15 | S5 | 2608h | 2608h | FS_ONAPDCAE | 40 | ORANGE (Jean-Michel Cornily | jeanmichel.cornily@orange.com | Rel-16 | 78 | 28.900 |  |  |
| 2653 | 1112 | Study on management aspects of edge computing |  | 202d? | 2018-06-06 A | 2019-03-14 A | 100% |  |  | finish no earlier than 2019-03-14 | S5 | 1616h | 1616h | FS_MAN_EC | 41 | Joey Chou, Intel | joey<dot>chou<at>intel<dot>com | Rel-16 | 80 | New; 28.803 |  |  |
| 2654 | 1113 | Study on self-evaluation towards IMT-2020 submission |  | 653d? | 2016-12-14 A | 2019-06-14 A | 100% |  |  | finish no earlier than 2019-06-15 | ITU-R AH; ITU-RAH | 10448h | 10448h | FS_5G_eval | 38 | Huawei |  | Rel-16 | 75 |  |  |  |
| 2655 | 1114 | Study on management aspects of communication services |  | 202d? | 2018-09-06 A | 2019-06-14 A | 100% |  |  | finish no earlier than 2019-06-14 | S5 | 1616h | 1616h | FS_CSMAN | 41 | Groenendijk, Jan, Ericsson | jan<dot>Groenendijk<at>ericsson<dot>com. | Rel-16 | 81 | New |  |  |
| 2656 | 1115 | Study on Typical Traffic Characteristics of Media Services |  | 378d? | 2018-10-02 A | 2020-03-12 A | 100% |  |  | finish no earlier than 2020-03-12 | S4 | 3024h | 3024h | FS_TyTrac | 41 | Thomas Stockhammer, Qualcomm Incorporated | tsto@qti.qualcomm.com | Rel-16 | 81 | 26.9xx |  |  |
| 2657 | 1116 | Study on non-file-based trace reporting |  | 135d? | 2018-12-06 A | 2019-06-12 A | 100% |  |  | finish no earlier than 2019-06-12 | S5 | 1080h | 1080h | FS_OAM_RTT | 42 | Andrianov, Anatoly, Nokia | anatoly.andrianov@nokia.com | Rel-16 | 82 |  |  |  |
| 2658 | 1117 | Study on ambient noise test methodology for evaluation of acoustic UE performance |  | 266d | 2018-12-06 A | 2019-12-12 A | 100% |  |  | finish no earlier than 2019-12-12 | S4 | 2128h | 2128h | FS_ANTeM | 42 | Jan Reimes, HEAD acoustics GmbH | jan.reimes@head-acoustics.de | Rel-16 | 82 |  |  |  |
| 2659 | 1118 | Stopped - Study on supporting Flexible Local Area Data Network |  | 202d? | 2018-06-06 A | 2019-03-14 A | 100% |  |  | finish no earlier than 2019-03-14 | S2 | 1616h | 1616h | FS_FLADN | 41 | LG Electronics, | hyuns.kim@lge.com | Rel-16 | 80 | New |  | 84 |
| 2660 | 1119 | Stopped - Study on encrypted traffic detection |  | 528d? | 2017-06-05 A | 2019-06-12 A | 100% |  |  | finish no earlier than 2019-06-12 | S2 | 4224h | 4224h | FS_ENTRADE | 39 | Chi Ren, China Unicom | renchi1@chinaunicom.cn | Rel-16 | 76 | new 23.787 |  | 84 |
| 2661 | 1120 | Study on storage and transport of 5GC security parameters for ARPF authentication |  | 387d | 2019-09-19 A | 2021-03-12 A | 100% |  |  | finish no earlier than 2021-03-12 | S3 | 3096h | 3096h | FS_5GC_SEC_ARPF | 43 | Evans, Timothy, Vodafone | tim.evans1@vodafone.com | Rel-16 | 85 | New ; 33.502 |  |  |
| 2662 | 1121 | --- RELEASE 15 --- | milestone | 0d? | 2016-03-15 A | 2016-03-15 A | 100% |  |  | finish no earlier than 2016-03-15 |  |  |  |  |  |  |  | Rel-15 |  |  |  |  |
| 2663 | 1122 | Release 15 Features on 5G | milestone | 0d? | 2016-06-09 A | 2016-06-09 A | 100% |  |  | finish no earlier than 2016-06-09 |  |  |  |  |  |  |  | Rel-15 |  |  |  |  |

Notes:
- 2602: ; 25/3/20: WID:CP-192019->CP-200059
- 2603: 6/8/18: 22.943 added;¦10/9/18: 0%->5¦10/12/18: 5%->25¦14/3/19: 25%->50; 31/5/19: 50%->90; 6/12/19: 90%->100
- 2604: 2/7/20: deleted, put at 100% (was at 0)
- 2605: ; 26/3/20: 0%->90; 26/6/20: 90%->100
- 2606: ; 6/12/19: 0%->65; 26/3/20: 65%->100
- 2607: ; 6/12/19: 0%->65; 26/3/20: 65%->100
- 2608: ; 6/12/19: 0%->65; 26/3/20: 65%->100
- 2609: 31/5/19: 0%->10; 13/9/19: 10%->25; 13/9/19: FCD:05/03/2020->03/20; 26/3/20: 25%->100
- 2610: 25/3/20: 0%->100
- 2611: ; 25/3/20: 0%->100
- 2612: ; 26/3/20: 0%->50; 28/6/20: 50%->100
- 2613: ; 26/3/20: 0%->100
- 2614: ; 26/3/20: 0%->100
- 2615: ; 6/12/19: 0%->5; 26/3/20: 5%->85; 2/7/20: 85%->100
- 2616: 31/5/19: 0%->10; 6/12/19: 10%->100
- 2617: ; 6/12/19: 0%->5; 26/3/20: 5%->85; 2/7/20: 85%->100
- 2618: ; 26/3/20: 0%->33; 26/6/20: 33%->100
- 2619: ; 26/6/20: 0%->100
- 2620: tested: REL-16 TEI16 CR set (R2-2000238, R2-2002121, R2-2000240) of RP-200357 and (R4-2008551, R4-2008540) of RP-201055 ; 8/4/21: 0%->71; 2/7/21: FCD:Thu 17/06/->09/21; 29/9/21: 71%->100
- 2621: tested: REL-16 TEI CRs of SA2/CT1/R2; compare LTE REL-14 WI EIEI-UEConTest "Evolution to and Interworking with eCall in IMS" ; 2/7/21: 0%->5; 22/3/22: 20/6/22: Rapporteur: Qualcomm->Bharadwaj Kumar Cheruvu, Qualcomm; Rap eMail: ->bcheruvu[at]qti.q...;...; 17/3/23: FCD:28/02/2023->03/03/2023; Compl:98%->100%; Stat Rep: RP-223382->RP-230094;
- 2622: 20/6/22: FCD:12/06/2023->09/20; 6/6/23: Compl:90%->98%
- 2626: -
- 2627: -
- 2628: 03/22: stopped at 0% ("deprioritised"in SA2 language)
- 2629: 27/3/18: 33.856 added;¦7/6/18: 0%->50¦10/9/18: 50%->79¦7/12/18: 79%->100
- 2630: 16/3/18: 0%->30¦7/6/18: 30%->55¦10/9/18: 55%->60¦7/12/18: 60%->100
- 2631: 16/3/18: 0%->5¦2/10/18: WID:CP-173160->CP-182052¦2/10/18: FCD:09/18->06/19¦14/3/19: 20%->70; 31/5/19: 70%->90; 14/1/20: 90%->100
- 2632: 7/6/18: 0%->30¦6/8/18: 23.727 added; 03/22: stopped at 30% ("deprioritised"in SA2 language)
- 2633: 14/1/20: 0%->100
- 2634: TR 38.8xx¦see follow-up REL-16 WI NR_CLI_RIM¦16/1/19: 0%->100
- 2635: TR 37.8XX, related to SON, MDT; 26/6/19: 0%->100
- 2636: related REL-15 SI FS_NR_test_methods; 23/1/20: 0%->45; 23/1/20: WID:RP-181402->RP-182305; 28/7/20: WID:RP-182305->RP-201069; 28/7/20: 45%->100
- 2637: TR 38.8XX¦16/1/19: 0%->100
- 2638: TR 38.8XX¦19/6/17: Compl:0%->10%¦19/6/17: WID: RP-170824->RP-171021¦30/6/17: 38.810 added;19/9/17: Compl:10%->15%19/9/17: WID: RP-171021->RP-171828¦8/1/18: Compl:15%->20%27/3/18: Compl:20%->45%27/3/18: CD:Thu 15/ ¦2¦16/1/19: 75%->100
- 2639: TR 38.8XX¦19/6/17: WID: RP-170829->RP-171043¦30/6/17: 32.812 added;¦27/6/18: Compl:0%->40%¦27/6/18: CD:Fri 15/06/18->Sat 15/12/18¦27/6/18: WID: RP-171043->RP-181403;¦16/1/19: 40%->100
- 2640: 7/12/18: 0%->55¦20/3/19: 55%->100
- 2641: 11/9/17: 0%->10¦15/12/17: 10%->70¦15/12/17: FCD:12/17->03/18¦16/3/18: 70%->90¦16/3/18: FCD:03/18->06/18¦7/6/18: FCD:06/18->12/18. 10/9/18: moved from Rel-15 as per SP-180687¦7/12/18: 90%->100
- 2642: 2/10/18: Moved from Rel-17. 17/01/19: acronym corrected from FS_XR5G¦12/3/19: 0%->35; 31/5/19: 35%->45; 13/9/19: 45%->60; 13/9/19: FCD:13/12/2019->03/20; 25/3/20: 60%->100; 25/9/20: 26.998 added;
- 2643: TR. 38.8xx¦26/3/19: WID:RP-182884->RP-190373; 8/10/19: WID:RP-190373->RP-192076; 28/7/20: 0%->100
- 2644: 31/5/19: 0%->10; 13/9/19: 10%->100
- 2645: 26/6/19: WID:RP-190702->RP-191481; 8/10/19: WID:RP-191481->RP-191975; 8/10/19: 38.823 added;; 14/1/20: 0%->100
- 2646: compare: REL-11 SI FS_UE_App_Data_Perf; TR 37.9xx. 07/2019: title changed from "…UE 5G NR…"; 8/10/19: 37.901-5 added;; 14/1/20: WID:RP-191590->RP-192712; 8/10/20: 0%->87; 8/10/20: FCD:13/03/2020->12/20; 6/1/21: WID:RP-192712->RP-202849; 7/4/21: WID:RP-
- 2647: -
- 2648: 15/12/17: 22.822 added;¦15/12/17: 0%->30¦15/12/17: FCD:12/17->06/18¦16/3/18: 30%->70¦7/6/18: 70%->100
- 2649: 11/9/17: 0%->20¦15/12/17: 22.823 added;¦15/12/17: 20%->75¦16/3/18: 75%->100; 25/9/20: 26.998 added;
- 2650: 6/8/18: 28.823 added;; 26/3/20: FCD:14/03/2019->06/20; 25/9/20: Stopped, so 0%->100
- 2651: 10/9/18: 0%->5¦7/12/18: 5%->60¦14/12/18: WID:SP-180388->SP-181075¦14/3/19: 60%->100; 26/6/19: 28.890 added;
- 2652: 16/3/18: 0%->10¦27/3/18: 28.900 added;¦7/6/18: 10%->20¦7/6/18: FCD:09/18->03/19¦15/6/18: WID:SP-170948->SP-180389¦10/9/18: 20%->35¦7/12/18: 35%->80¦14/12/18: WID:SP-180389->SP-181074¦14/3/19: 80%->100
- 2653: 6/8/18: 28.803 added;¦10/9/18: 0%->10¦7/12/18: 10%->20¦14/3/19: 20%->50; 31/5/19: 50%->65; 13/9/19: 65%->100
- 2654: TR 38.9XX¦19/6/17: CD:Sat 15/09/18->Fri 15/06/18¦19/6/17: WID: RP-170832->RP-171451¦19/6/17: Release: Rel-16->Rel-15¦8/1/18: Compl:0%->15%27/3/18: Compl:15%->25%¦27/6/18: Compl:25%->35%¦27/6/18: CD:Fri 15/0; 26/6/19: 35%->100
- 2655: 7/12/18: 0%->40¦14/3/19: 40%->70; 31/5/19: 70%->75; 13/9/19: 75%->100
- 2656: 2/10/18: Moved from Rel-17¦12/3/19: 0%->45; 31/5/19: 45%->50; 13/9/19: 50%->60; 13/9/19: FCD:13/12/2019->03/20; 25/3/20: 60%->100
- 2657: 13/9/19: 0%->100
- 2658: 12/3/19: 0%->10; 31/5/19: 0%->10; 31/5/19: 0%->10; 13/9/19: 10%->70; 25/3/20: 70%->100
- 2659: 10/9/18: FCD:12/18->03/19¦6/6/19: stopped at 0% as per SP-190395
- 2660: ¦15/12/17: Changed Rel-15->Rel-16¦16/3/18: WID:SP-170381->SP-170934¦16/3/18: 0%->20¦7/6/18: 20%->70¦14/12/18: FCD:09/18->06/19. Name changed; 22/3/22: stopped at 70% ("deprioritised"in SA2 language)
- 2661: ; 8/10/19: 33.502 added;; 6/12/19: 0%->30; 6/12/19: FCD:12/12/2019->03/20; 26/6/20: FCD:12/03/2020->09/20; 26/6/20: 30%->60; 12/9/20: 60%->75; 12/9/20: FCD:15/09/2020->12/20; 5/12/20: 75%->90; 5/12/20: FCD:15/12/2020->03/20; 19/3/21: 90%->98; 11/6/21:
- 2662: -
- 2663: -

| ID | WBS | Task | Duration | Start | Finish | Complete | Remaining | Total slack | Constraint | Resources | Work | Actual work | Acronym | PCG approved | WI rapporteur name | WI rapporteur e-mail | Release | TSG approved |
| --- | --- | --- | --- | --- | --- | --- | --- | --- | --- | --- | --- | --- | --- | --- | --- | --- | --- | --- |
| 2664 | 1123 | **5G System - Phase 1** | 788d? | 2016-06-09 A | 2019-06-14 | 97% | 21.13d? | 1756d |  |  | 55632h | 52936h | 5GS_Ph1 | 38 | China Mobile, Tao Sun | suntao@chinamobile.com | Rel-15 | 74 |
| 2665 | 1123.1 | Study on Charging Aspects of 5G System Architecture Phase 1 | 206d? | 2017-03-03 A | 2017-12-15 A | 100% |  |  | finish no earlier than 2017-12-15 | S5 | 1648h | 1648h | FS_5GS_Ph1_CH | 38 | Chen, Shan, Huawei | chenshan@huawei.com | Rel-15 | 75 |
| 2666 | 1123.2 | (Stage 1 of 5G) New Services and Markets Technology Enablers | 201d? | 2016-06-09 A | 2017-03-15 A | 100% |  |  | finish no earlier than 2017-03-15 | S1 | 1608h | 1608h | SMARTER | 37 | Li, Alice | alice.li@vodafone.com | Rel-15 | 72 |
| 2667 | 1123.3 | Stage 2 of 5G System - Phase 1 | 271d? | 2016-12-01 A | 2017-12-14 A | 100% |  |  | finish no earlier than 2017-12-14 | S2 | 2168h | 2168h | 5GS_Ph1 | 38 | China Mobile, Tao Sun | suntao@chinamobile.com | Rel-15 | 74 |
| 2668 | 1123.4 | Security aspects of 5G System - Phase 1 | 337d? | 2017-03-02 A | 2018-06-15 A | 100% |  |  | finish no earlier than 2018-06-15 | S3 | 2696h | 2696h | 5GS_Ph1-SEC | 38 | NTT DOCOMO, Alf Zugenmaier | alf.zugenmaier@hm.edu | Rel-15 | 75 |
| 2669 | 1123.5 | Security aspects of 5G System - Phase 1 IETF | 337d? | 2017-03-02 A | 2018-06-15 | 50% | 168.5d? | 2016d | finish no earlier than 2018-06-15 | S3-IETF | 2696h |  | 5GS_Ph1-SEC | 44 |  |  | Rel-15 | 87 |
| 2670 | 1123.6 | **CT aspects of 5G System - Phase 1** | 335d? | 2017-03-03 A | 2018-06-14 A | 100% |  |  |  | ct | 30600h | 30600h | 5GS_Ph1-CT | 38 | Song Yue (China Mobile) | songyue at chinamobile.com | Rel-15 | 75 |
| 2671 | 1123.6.1 | **Studies on CT1 aspects of 5G System - Phase 1** | 205d? | 2017-03-03 A | 2017-12-14 A | 100% |  |  |  |  | 11480h | 11480h | 5GS_Ph1-CT | 38 | Herrero Veron, Christian (Huawei) | Christian.Herrero at huawei.com | Rel-15 | 75 |
| 2672 | 1123.6.1.1 | Study on 5G Network selection | 205d? | 2017-03-03 A | 2017-12-14 A | 100% |  |  | finish no earlier than 2017-12-14 | C1 | 1640h | 1640h | 5GS_Ph1-CT | 39 | Herrero Veron, Christian (Huawei) | Christian.Herrero at huawei.com | Rel-15 | 77 |
| 2673 | 1123.6.1.2 | Study on 5G Mobility management | 205d? | 2017-03-03 A | 2017-12-14 A | 100% |  |  | finish no earlier than 2017-12-14 | C1 | 1640h | 1640h | 5GS_Ph1-CT | 39 | Herrero Veron, Christian (Huawei) | Christian.Herrero at huawei.com | Rel-15 | 77 |
| 2674 | 1123.6.1.3 | Study on 5G Session management | 205d? | 2017-03-03 A | 2017-12-14 A | 100% |  |  | finish no earlier than 2017-12-14 | C1 | 1640h | 1640h | 5GS_Ph1-CT | 39 | Herrero Veron, Christian (Huawei) | Christian.Herrero at huawei.com | Rel-15 | 77 |
| 2675 | 1123.6.1.4 | Study on 5G Non-3GPP access networks | 205d? | 2017-03-03 A | 2017-12-14 A | 100% |  |  | finish no earlier than 2017-12-14 | C1 | 1640h | 1640h | 5GS_Ph1-CT | 39 | Herrero Veron, Christian (Huawei) | Christian.Herrero at huawei.com | Rel-15 | 77 |
| 2676 | 1123.6.1.5 | Study on 5G Interworking with EPC | 205d? | 2017-03-03 A | 2017-12-14 A | 100% |  |  | finish no earlier than 2017-12-14 | C1 | 1640h | 1640h | 5GS_Ph1-CT | 39 | Herrero Veron, Christian (Huawei) | Christian.Herrero at huawei.com | Rel-15 | 77 |
| 2677 | 1123.6.1.6 | Study on 5G System core network impact on services, network functions and capabilities | 205d? | 2017-03-03 A | 2017-12-14 A | 100% |  |  | finish no earlier than 2017-12-14 | C1 | 1640h | 1640h | 5GS_Ph1-CT | 39 | Herrero Veron, Christian (Huawei) | Christian.Herrero at huawei.com | Rel-15 | 77 |
| 2678 | 1123.6.1.7 | Study on 5G Network slicing | 205d? | 2017-03-03 A | 2017-12-14 A | 100% |  |  | finish no earlier than 2017-12-14 | C1 | 1640h | 1640h | 5GS_Ph1-CT | 39 | Herrero Veron, Christian (Huawei) | Christian.Herrero at huawei.com | Rel-15 | 77 |
| 2679 | 1123.6.2 | **CT1 aspects of 5G System - Phase 1 (normative work)** | 130d? | 2017-12-15 A | 2018-06-14 A | 100% |  |  |  | C1 | 8320h | 8320h | 5GS_Ph1-CT | 38 | Herrero Veron, Christian (Huawei) | Christian.Herrero at huawei.com | Rel-15 | 75 |
| 2680 | 1123.6.2.1 | 5G Network selection | 130d? | 2017-12-15 A | 2018-06-14 A | 100% |  |  | finish no earlier than 2018-06-14 | C1 | 1040h | 1040h | 5GS_Ph1-CT | 39 | Herrero Veron, Christian (Huawei) | Christian.Herrero at huawei.com | Rel-15 | 77 |
| 2681 | 1123.6.2.2 | 5G Mobility management | 130d? | 2017-12-15 A | 2018-06-14 A | 100% |  |  | start no earlier than 2017-12-15 | C1 | 1040h | 1040h | 5GS_Ph1-CT | 39 | Herrero Veron, Christian (Huawei) | Christian.Herrero at huawei.com | Rel-15 | 77 |
| 2682 | 1123.6.2.3 | 5G Session management | 130d? | 2017-12-15 A | 2018-06-14 A | 100% |  |  | start no earlier than 2017-12-15 | C1 | 1040h | 1040h | 5GS_Ph1-CT | 39 | Herrero Veron, Christian (Huawei) | Christian.Herrero at huawei.com | Rel-15 | 77 |
| 2683 | 1123.6.2.4 | 5G Non-3GPP access networks | 130d? | 2017-12-15 A | 2018-06-14 A | 100% |  |  | start no earlier than 2017-12-15 | C1 | 1040h | 1040h | 5GS_Ph1-CT | 39 | Herrero Veron, Christian (Huawei) | Christian.Herrero at huawei.com | Rel-15 | 77 |
| 2684 | 1123.6.2.5 | 5G Interworking with EPC | 130d? | 2017-12-15 A | 2018-06-14 A | 100% |  |  | start no earlier than 2017-12-15 | C1 | 1040h | 1040h | 5GS_Ph1-CT | 39 | Herrero Veron, Christian (Huawei) | Christian.Herrero at huawei.com | Rel-15 | 77 |
| 2685 | 1123.6.2.6 | 5G System core network impact on services, network functions and capabilities | 130d? | 2017-12-15 A | 2018-06-14 A | 100% |  |  | start no earlier than 2017-12-15 | C1 | 1040h | 1040h | 5GS_Ph1-CT | 39 | Herrero Veron, Christian (Huawei) | Christian.Herrero at huawei.com | Rel-15 | 77 |
| 2686 | 1123.6.2.7 | 5G Network slicing | 130d? | 2017-12-15 A | 2018-06-14 A | 100% |  |  | start no earlier than 2017-12-15 | C1 | 1040h | 1040h | 5GS_Ph1-CT | 39 | Herrero Veron, Christian (Huawei) | Christian.Herrero at huawei.com | Rel-15 | 77 |
| 2687 | 1123.6.3 | Study on CT3 aspects of 5G System - Phase 1 | 205d? | 2017-03-03 A | 2017-12-14 A | 100% |  |  | finish no earlier than 2017-12-14 | C3 | 1640h | 1640h | 5GS_Ph1-CT | 38 | Fernandez, Susana (Ericsson) | Susana.Fernandez at ericsson.com | Rel-15 | 75 |
| 2688 | 1123.6.4 | CT3 aspects of 5G System - Phase 1 | 130d? | 2017-12-15 A | 2018-06-14 A | 100% |  |  | start no earlier than 2017-12-15 | C3 | 1040h | 1040h | 5GS_Ph1-CT | 38 | Fernandez, Susana (Ericsson) | Susana.Fernandez at ericsson.com | Rel-15 | 75 |
| 2689 | 1123.6.5 | CT4 aspects of 5G System - Phase 1 | 205d? | 2017-03-03 A | 2017-12-14 A | 100% |  |  | finish no earlier than 2017-12-14 | C4 | 1640h | 1640h | 5GS_Ph1-CT | 38 | Landais, Bruno (Nokia) | Bruno.Landais at nokia.com | Rel-15 | 75 |
| 2690 | 1123.6.6 | (IETF) Improved Extensible Authentication Protocol Method for 3GPP Mobile Network Authentication and Key Agreement (EAP-AKA') (draft-ietf-emu-rfc5448bis) | 205d? | 2017-03-03 A | 2017-12-14 A | 100% |  |  | finish no earlier than 2017-12-14 | C4-IETF | 1640h | 1640h | 5GS_Ph1-CT | 44 |  |  | Rel-15 | 87 |
| 2691 | 1123.6.7 | Study on CT6 aspects of 5G System - Phase 1 | 205d? | 2017-03-03 A | 2017-12-14 A | 100% |  |  | finish no earlier than 2017-12-14 | C6 | 1640h | 1640h | 5GS_Ph1-CT | 38 | Amandeep Virk from Qualcomm |  | Rel-15 | 75 |
| 2692 | 1123.6.8 | CT6 aspects of 5G System - Phase 1 | 65d? | 2018-03-16 A | 2018-06-14 A | 100% |  |  | finish no earlier than 2018-06-14 | C6 | 520h | 520h | 5GS_Ph1-CT | 38 | Landais, Bruno (Nokia) | Bruno.Landais at nokia.com | Rel-15 | 75 |
| 2693 | 1123.7 | UE Conformance Test Aspects – 5G System Non-3GPP Access | 196d? | 2018-06-15 A | 2019-03-15 A | 100% |  |  | finish no earlier than 2019-03-15 | R5 | 1568h | 1568h | 5GS_Ph1-CT_n3GPPA-UEConTest | 41 | Motorola |  | Rel-15 | 80 |

Notes:
- 2664: 15/12/17: 23.503 added;
- 2665: 7/6/17: 0%->15¦11/9/17: 15%->60¦11/9/17: WID:SP-170128->SP-170659¦15/12/17: 60%->100¦21/12/17: WID:SP-170659->SP-170953
- 2666: Resulting from FS_SMARTER¦19/9/16: 0%->55¦6/10/16: 22.261 added¦1/12/16: FCD:09/16->03/20¦1/12/16: 55%->75¦2/3/17: 75%->90¦7/6/17: 90%->100 / Impacted TSs and TRs: 22.261
- 2667: 3/3/17: 0%->30¦7/6/17: 30%->55¦11/9/17: 55%->75¦21/12/17: 75%->95¦11/6/18: 95%->100 / Impacted TSs and TRs: 23.401; 23.167; 23.271; 23.002; 23.228; 23.401; 23.167; 23.271; 23.502; 23.501; 23.503
- 2668: 7/6/17: 0%->10¦11/9/17: 10%->30¦15/12/17: 30%->65¦21/12/17: WID:SP-170234->SP-170881¦16/3/18: 65%->85¦16/3/18: FCD:03/18->06/18¦7/6/18: 85%->95¦10/9/18: WID:SP-170881->100¦10/9/18: 95%->100¦2/10/18: WID:SP-170881->SP-180693 / Impacted TSs and TRs: 33.501; 33.401; 33.210; 33.310; 33.220
- 2670: 6/17: WID:CP-170204->CP-171105¦9/17: WID:CP-171105->CP-172034. Rapp changed, impacted TS clarified¦12/17: added: 24.501 ¦24.502 ¦29.520 added¦29.514¦29.513 ¦29.520a¦29.514a¦12/17: 29.519 added¦29.516 added;¦: 2.. 3/18: 29.554 added;29.59¦6 / Impacted TSs and TRs: 24.501; 24.502; 29.520; 29.514; 29.513; ; 29.520a; 29.514a; 29.519; 29.516; 29.512; 29.508; 29.507; 29.551; 29.554; 29.522; 24.568; 29.521; 29.525; 29.524; 29.523
- 2671: 18/12/17: WID:CP-172034->CP-173161 / Impacted TSs and TRs: 23.122; 23.040; 23.041; 24.007; 24.301; 24.008; 24.302; 24.011; 24.312; 24.305; 24.368; 27.007
- 2672: Task introduced as per CT1's chair e-mail¦11/9/17: 10%->55¦15/12/17: 55%->80¦16/3/18: 80%->100
- 2673: Task introduced as per CT1's chair e-mail¦11/9/17: 40%->70¦15/12/17: 70%->100
- 2674: Task introduced as per CT1's chair e-mail¦11/9/17: 35%->75¦15/12/17: 75%->100
- 2675: Task introduced as per CT1's chair e-mail¦11/9/17: 15%->55¦15/12/17: 55%->100
- 2676: Task introduced as per CT1's chair e-mail¦11/9/17: 15%->45¦15/12/17: 45%->100
- 2677: Task introduced as per CT1's chair e-mail¦11/9/17: 20%->65¦15/12/17: 65%->85¦16/3/18: 85%->100
- 2678: Task introduced as per CT1's chair e-mail¦11/9/17: 10%->45¦15/12/17: 45%->100
- 2679: Impacted TSs and TRs: 23.122; 23.040; 23.041; 24.007; 24.301; 24.008; 24.302; 24.011; 24.312; 24.305; 24.368; 27.007
- 2680: 16/3/18: 0%->60¦7/6/18: 60%->100
- 2681: 15/12/17: 0%->25¦16/3/18: 25%->70¦7/6/18: 70%->95¦10/9/18: 95%->100
- 2682: 15/12/17: 0%->35¦16/3/18: 35%->85¦7/6/18: 85%->100
- 2683: 15/12/17: 0%->20¦16/3/18: 20%->60¦7/6/18: 60%->95¦10/9/18: 95%->100
- 2684: 15/12/17: 0%->20¦16/3/18: 20%->60¦7/6/18: 60%->100
- 2685: 15/12/17: 0%->10¦16/3/18: 10%->70¦7/6/18: 70%->90¦10/9/18: 90%->100
- 2686: 15/12/17: 0%->10¦16/3/18: 10%->60¦7/6/18: 60%->100
- 2687: 5/6/17: 0%->20¦15/12/17: 20%->95¦22/3/18: 95%->100 / Impacted TSs and TRs: 29.213; 29.214; 29.219; 29.122
- 2688: 5/6/17: 0%->20¦15/12/17: 20%->95¦7/6/18: 35%->70¦7/6/18: 70%->100 / Impacted TSs and TRs: 29.213; 29.214; 29.219; 29.122
- 2689: 5/6/17: 0%->5¦11/9/17: 5%->25¦15/12/17: 25%->45¦16/3/18: 45%->50¦7/6/18: 50%->95¦10/9/18: 95%->99¦10/12/18: 99%->100 / Impacted TSs and TRs: 23.003; 23.008; 23.380; 29.281; 29.272; 29.274; 29.303
- 2690: 20/6/22: Compl:80%->100%
- 2691: 5/6/17: 0%->10¦11/9/17: 10%->60¦15/12/17: 60%->85¦22/3/18: 85%->95¦7/6/18: 95%->100
- 2692: 5/6/17: 0%->5¦11/9/17: 5%->25¦15/12/17: 25%->45¦16/3/18: 45%->50¦16/3/18: 0%->20¦7/6/18: 20%->90¦10/9/18: 90%->95. 10/9/18: 95->100 as per CT81 discussions¦10/12/18: 100%->95¦11/12/18: 95%->100 / Impacted TSs and TRs: 23.003; 23.008; 23.380; 29.281; 29.272; 29.274; 29.303
- 2693: tested: non-3GPP Access part of REL-15 WI 5GS_Ph1-CT (note: 3GPP Access part of 5GS_Ph1-CT is already covered in REL-15 WI 5GS_NR_LTE-UEConTest);; 26/3/20: 0%->100

| ID | WBS | Task | Type | Duration | Start | Finish | Complete | Remaining | Total slack | Constraint | Resources | Work | Actual work | Acronym | PCG approved | WI rapporteur name | WI rapporteur e-mail | Release | TSG approved | Status Report |
| --- | --- | --- | --- | --- | --- | --- | --- | --- | --- | --- | --- | --- | --- | --- | --- | --- | --- | --- | --- | --- |
| 2694 | 1123.8 | **IMS impact due to 5GS IP-CAN** |  | 205d? | 2017-09-04 A | 2018-06-15 A | 100% |  |  |  | ct | 6560h | 6560h | 5GS_Ph1-IMSo5G | 39 | Song Yue (China Mobile) | songyue (at) chinamobile (dot) com | Rel-15 | 76 |  |
| 2695 | 1123.8.1 | CT1 aspects of IMSo5G |  | 205d? | 2017-09-04 A | 2018-06-15 A | 100% |  |  | finish no earlier than 2018-06-15 | C1 | 1640h | 1640h | 5GS_Ph1-IMSo5G | 39 | Song Yue, China Mobile | songyue@chinamobile.com | Rel-15 | 77 |  |
| 2696 | 1123.8.2 | CT3 aspects of IMSo5G |  | 205d? | 2017-09-04 A | 2018-06-15 A | 100% |  |  | finish no earlier than 2018-06-15 | C3 | 1640h | 1640h | 5GS_Ph1-IMSo5G | 39 | Herrero Veron, Christian (Huawei) | Christian.Herrero at huawei.com | Rel-15 | 77 |  |
| 2697 | 1123.8.3 | CT4 aspects of IMSo5G |  | 205d? | 2017-09-04 A | 2018-06-15 A | 100% |  |  | finish no earlier than 2018-06-15 | C4 | 1640h | 1640h | 5GS_Ph1-IMSo5G | 39 | Herrero Veron, Christian (Huawei) | Christian.Herrero at huawei.com | Rel-15 | 77 |  |
| 2698 | 1123.9 | Service Based Interface for 5G Charging |  | 196d? | 2017-12-15 A | 2018-09-14 A | 100% |  |  | finish no earlier than 2018-09-14 | S5 | 1568h | 1568h | 5GS_Ph1-SBI_CH | 40 | Chen, Shan, Huawei | chenshan@huawei.com | Rel-15 | 78 |  |
| 2699 | 1123.10 | Data Charging in 5G System Architecture Phase 1 |  | 196d? | 2017-12-15 A | 2018-09-14 A | 100% |  |  | finish no earlier than 2018-09-14 | S5 | 1568h | 1568h | 5GS_Ph1-DCH | 40 | Gardella, Maryse, Nokia | maryse.gardella@nokia.com | Rel-15 | 78 |  |
| 2700 | 1123.11 | SMS Charging in 5G System Architecture Phase 1 |  | 72d? | 2018-09-06 A | 2018-12-14 A | 100% |  |  | finish no earlier than 2018-12-14 | S5 | 576h | 576h | 5GS_Ph1-SMSCH | 41 | Gardella, Maryse, Nokia | maryse.gardella@nokia.com | Rel-15 | 81 |  |
| 2701 | 1123.12 | Charging for IMS over 5G System Architecture Phase 1 |  | 30d? | 2018-05-07 A | 2018-06-15 A | 100% |  |  | start no earlier than 2018-05-07 | S5 | 240h | 240h | 5GS_Ph1_IMSCH | 41 | Gardella, Maryse, Nokia | maryse.gardella@nokia.com | Rel-15 | 80 |  |
| 2702 | 1123.13 | UE Conformance Test Aspects - CT6 aspects of 5G System |  | 267d? | 2018-06-07 A | 2019-06-14 A | 100% |  |  | finish no earlier than 2019-06-14 | C6 | 2136h | 2136h | 5GS_Ph1_UEConTest | 41 | Azem, Dania (COMPRION GmbH) | DAzem@comprion.com | Rel-15 | 80 |  |
| 2703 | 1124 | **EPC enhancements to support 5G New Radio via Dual Connectivity** |  | 271d? | 2017-03-02 A | 2018-03-15 A | 100% |  |  |  |  | 8336h | 8336h | EDCE5 | 38 | Chris Pudney, Vodafone Group | Chris Pudney, Vodafone Group | Rel-15 | 75 |  |
| 2704 | 1124.1 | SA2 aspects of EDCE5 |  | 141d? | 2017-03-02 A | 2017-09-14 A | 100% |  |  | finish no earlier than 2017-09-14 | S2 | 1128h | 1128h | EDCE5 | 38 | Chris Pudney, Vodafone Group |  | Rel-15 | 75 |  |
| 2705 | 1124.2 | SA3 aspects of EDCE5 |  | 141d? | 2017-03-02 A | 2017-09-14 A | 100% |  |  | finish no earlier than 2017-09-14 | S3 | 1128h | 1128h | EDCE5 | 38 | Adrian Escott, Qualcomm Incorporated |  | Rel-15 | 75 |  |
| 2706 | 1124.3 | **CT aspects of EDCE5** |  | 139d? | 2017-06-05 A | 2017-12-14 A | 100% |  |  |  | ct | 4448h | 4448h | EDCE5-CT | 39 | Jesús de Gregorio, Ericsson | jesus.de.gregorio@ericsson.com | Rel-15 | 76 |  |
| 2707 | 1124.3.1 | CT1 aspects of EDCE5 |  | 139d? | 2017-06-05 A | 2017-12-14 A | 100% |  |  | finish no earlier than 2017-12-14 | C1 | 1112h | 1112h | EDCE5-CT | 39 | Jesús de Gregorio, Ericsson | jesus.de.gregorio@ericsson.com | Rel-15 | 76 |  |
| 2708 | 1124.3.2 | CT3 aspects of EDCE5 |  | 139d? | 2017-06-05 A | 2017-12-14 A | 100% |  |  | finish no earlier than 2017-12-14 | C3 | 1112h | 1112h | EDCE5-CT | 39 | Jesús de Gregorio, Ericsson | jesus.de.gregorio@ericsson.com | Rel-15 | 76 |  |
| 2709 | 1124.3.3 | CT4 aspects of EDCE5 |  | 139d? | 2017-06-05 A | 2017-12-14 A | 100% |  |  | finish no earlier than 2017-12-14 | C4 | 1112h | 1112h | EDCE5-CT | 39 | Jesús de Gregorio, Ericsson | jesus.de.gregorio@ericsson.com | Rel-15 | 76 |  |
| 2710 | 1124.4 | Charging aspects of EDCE5: PS Charging enhancements to support 5G New Radio via Dual Connectivity |  | 204d? | 2017-06-05 A | 2018-03-15 A | 100% |  |  | finish no earlier than 2018-03-15 | S5 | 1632h | 1632h | EDCE5-CH | 39 | Törnkvist, Robert, Ericsson | robert.tornkvist(at)ericsson.com | Rel-15 | 76 |  |
| 2711 | 1125 | **New Radio Access Technology** |  | 588d? | 2017-03-15 A | 2019-06-14 A | 100% |  |  |  | R1 | 13072h | 13072h | NR_newRAT | 38 | NTT DOCOMO |  | Rel-15 | 75 |  |
| 2712 | 1125.1 | Core part: New Radio Access Technology |  | 458d? | 2017-03-15 A | 2018-12-14 A | 100% |  |  | finish no earlier than 2018-12-15 | R1 | 3664h | 3664h | NR_newRAT-Core | 38 | NTT DOCOMO |  | Rel-15 | 75 | RP-181466 |
| 2713 | 1125.2 | Perf. part: New Radio Access Technology |  | 588d? | 2017-03-15 A | 2019-06-14 A | 100% |  |  | finish no earlier than 2019-06-15 | R4 | 4704h | 4704h | NR_newRAT-Perf | 38 | NTT DOCOMO |  | Rel-15 | 75 |  |
| 2714 | 1126 | **LTE connectivity to 5G-CN** |  | 462d? | 2017-03-15 A | 2018-12-20 A | 100% |  |  |  | R2 | 9432h | 9432h | LTE_5GCN_connect | 38 | Huawei |  | Rel-15 | 75 |  |
| 2715 | 1126.1 | Core part: LTE connectivity to 5G-CN |  | 393d? | 2017-03-15 A | 2018-09-14 A | 100% |  |  | finish no earlier than 2018-09-15 | R2 | 3144h | 3144h | LTE_5GCN_connect-Core | 38 | Huawei |  | Rel-15 | 75 | RP-180862 |
| 2716 | 1126.2 | Perf. part: LTE connectivity to 5G-CN |  | 393d? | 2017-06-20 A | 2018-12-20 A | 100% |  |  | finish no earlier than 2018-12-20 | R4 | 3144h | 3144h | LTE_5GCN_connect-Perf | 38 | Huawei |  | Rel-15 | 75 | RP-180862 |
| 2717 | 1127 | UE Conformance Test Aspects - 5G system with NR and LTE |  | 1175d? | 2017-06-15 A | 2021-12-14 | 87% | 152.75d? | 1103d | finish no earlier than 2021-12-15 | R5 | 9400h | 470.4h | 5GS_NR_LTE-UEConTest | 39 | Ericsson |  | Rel-15 | 76 |  |
| 2718 | 1128 | Release 15 Features on V2X | milestone | 0d? | 2016-06-09 A | 2016-06-09 A | 100% |  |  | finish no earlier than 2016-06-09 |  |  |  |  |  |  |  | Rel-15 |  |  |

Notes:
- 2694: 8/9/17: WID:CP-171103->CP-172033¦FCD: 12/17->06/18¦19/3/18: WID:CP-172033->CP-180094
- 2695: 14/9/17: 0%->10¦15/12/17: 10%->65¦rapporteur changed¦20/3/18: 65%->75¦7/6/18: 75%->95¦10/9/18: 95%->100 / Impacted TSs and TRs: 24.229; 24.167
- 2696: 7/6/18: 0%->80¦10/9/18: 80%->100 / Impacted TSs and TRs: 29.213; 29.214
- 2697: 7/6/18: 0%->100 / Impacted TSs and TRs: 23.008; 29.228; 29.229; 29.328; 29.329; 23.003
- 2698: 16/3/18: 0%->15¦7/6/18: 15%->55¦7/6/18: FCD:06/18->09/18¦10/9/18: 55%->100 / Impacted TSs and TRs: 32.240; 32.298
- 2699: 16/3/18: 0%->10¦7/6/18: 10%->60¦7/6/18: FCD:06/18->09/18¦10/9/18: 60%->100 / Impacted TSs and TRs: 32.240
- 2700: 7/12/18: 0%->100 / Impacted TSs and TRs: 32.240; 32.274; 32.290; 32.291; 32.299; 32.298
- 2701: 7/6/18: 0%->100 / Impacted TSs and TRs: 32.240; 32.260; 32.299; 32.298
- 2702: 10/12/18: 0%->5¦10/12/18: 5%->¦10/12/18: WID:CP-181187->CP-183242; 31/5/19: 5%->10; 6/12/19: 10%->60; 26/3/20: 60%->85; 26/6/20: 85%->95; 13/9/20: 95%->98; 13/12/21: 98%->100 / Impacted TSs and TRs: 31.121 ; 31.124
- 2703: 9/6/17: WID:SP-170058->SP-170583
- 2704: 7/6/17: 0%->55¦11/9/17: 55%->90¦15/12/17: 90%->100
- 2705: 7/6/17: 0%->60¦11/9/17: 60%->70¦15/12/17: 70%->100
- 2706: 18/12/17: WID:CP-171045->CP-173038
- 2707: 14/9/17: 0%->65¦15/12/17: 65%->100 / Impacted TSs and TRs: 24.301; 27.007
- 2708: Impacted TSs and TRs: 29.212; 29.213; 29.214; 29.215; 29.201
- 2709: 11/9/17: 0%->50¦15/12/17: 50%->100 / Impacted TSs and TRs: 23.008; 29.272; 29.230; 29.002; 29.305; 29.274
- 2710: 15/12/17: 0%->20¦16/3/18: 20%->100 / Impacted TSs and TRs: 32.251; 32.298; 32.299
- 2711: follow-up WI of REL-14 SI FS_NR_newRAT completed at RAN #75¦30/6/17: 38.425 added;¦14/9/17: WID:RP-170855->RP-171485¦15/12/17: added: 38.305¦38.113¦37.863-04-01¦37.863-03-01¦37.863-02-01¦38.820-04-01¦38.820-03-01¦38.820-02-01¦15/12/17: 37.32 / Impacted TSs and TRs: 38.425; 38.424; 38.423; 38.422; 38.421; 38.420; 38.305; 38.113; 37.863-04-01; 37.863-03-01; 37.863-02-01; 38.820-04-01; 38.820-03-01; 38.820-02-01; 37.324; 37.872; 37.864-11-22; 37.866-00-02
- 2712: follow-up WI of REL-14 SI FS_NR_newRAT¦19/6/17: Compl:0%->22%19/6/17: WID: RP-170855->RP-171485¦30/6/17 & 12/6/17: impacted specs added19/9/17: Compl:22%->50%19/9/17: WID: RP-171485->RP-172115¦15/12/17: added: 38.818¦37.865-01-01¦37.834-01-01¦37 .; 2 / Impacted TSs and TRs: 37.340;37.834-01-01;37.863-05-01;37.864-41-21;37.865-01-01;38.101;38.104;38.12?;38.201/2;38.211/2;38.213to215;38.300;38.304to307;38.321to323;38.331;38.401;38.410to414;38.455;38.470to475;38.815;38.817-01-02;38.818; 38.113; 29.413; 37.864-11-22; 38.415; 38.
- 2713: follow-up WI of REL-14 SI FS_NR_newRAT completed at RAN #75¦19/6/17: WID: RP-170855->RP-171485¦12/7/17: 38.133 added;¦12/7/17: 38.141 added;¦19/9/17: WID: RP-171485->RP-172115¦15/12/17: 38.101-4 added¦8/1/18: WID: RP-172115->RP-172834¦27/3/18: W ; 8 / Impacted TSs and TRs: 38.133; 38.141; 38.101-4; 38.171
- 2714: no Perf. part¦14/9/17: WID:RP-170840->RP-171432
- 2715: no Perf. Part19/6/17: Compl:0%->5%19/6/17: WID: RP-170840->RP-17143219/9/17: Compl:5%->10%¦8/1/18: Compl:10%->20%¦27/3/18: Compl:20%->30%¦ ¦27/6/18: Compl:30%->99%¦7/3/19: 99%->100
- 2716: 16/1/19: 0%->100
- 2717: ¦19/9/17: Compl:0%->2%¦15/12/17: impacted specs add¦15/12/17: 38.508-2 added;¦ ;; 8/10/19: WID:RP-181206->RP-192123; 8/10/19: 34.229-5 added;; 24/4/20: FCD:14/12/2018->12/20; 24/4/20: 15%->69; 8/10/20: 69%->79; 8/10/20: FCD:15/12/2020->12/20; 7/4/21: W / Impacted TSs and TRs: 38.507-1; 38.533; 38.522; 38.521-1-2-3; 38.508; 38.509; 38.903; 38.905; 38.523-1-2-3; ; 38.508-2; 34.229-5
- 2718: -

| ID | WBS | Task | Type | Duration | Start | Finish | Complete | Remaining | Total slack | Constraint | Resources | Work | Actual work | Acronym | PCG approved | WI rapporteur name | WI rapporteur e-mail | Release | TSG approved | Impacted TSs and TRs | Status Report |
| --- | --- | --- | --- | --- | --- | --- | --- | --- | --- | --- | --- | --- | --- | --- | --- | --- | --- | --- | --- | --- | --- |
| 2719 | 1129 | **Enhancement of 3GPP support for V2X scenarios** |  | 206d? | 2016-06-09 A | 2017-03-22 A | 100% |  |  |  |  | 1520h | 1520h | eV2X | 38 | Chun, SungDuck, LG Electronics | sungduck.chun@lge.com | Rel-15 | 75 |  |  |
| 2720 | 1129.1 | Study on Enhancement of 3GPP support for V2X services |  | 137d? | 2016-06-09 A | 2016-12-15 A | 100% |  |  | finish no earlier than 2016-12-15 | S1 | 1096h | 1096h | FS_eV2X | 37 | LG Electronics, SungDuck Chun | sungduck.chun@lge.com | Rel-15 | 72 | 22.886 |  |
| 2721 | 1129.2 | Stage 1 of Enhancement of 3GPP support for V2X scenarios |  | 53d? | 2017-01-09 A | 2017-03-22 A | 100% |  |  | finish no earlier than 2017-03-22 | S1 | 424h | 424h | eV2X | 38 | Chun, SungDuck, LG Electronics | sungduck.chun@lge.com | Rel-15 | 75 | 22.186 |  |
| 2722 | 1130 | **V2X new band combinations for LTE** |  | 328d? | 2017-03-15 A | 2018-06-15 A | 100% |  |  |  | R4 | 5248h | 5248h | LTE_V2X_CA_bands | 38 | LG Electronics |  | Rel-15 | 75 | 36.787 |  |
| 2723 | 1130.1 | Core part: V2X new band combinations for LTE |  | 328d? | 2017-03-15 A | 2018-06-15 A | 100% |  |  | finish no earlier than 2018-06-15 | R4 | 2624h | 2624h | LTE_V2X_CA_bands-Core | 38 | LG Electronics |  | Rel-15 | 75 |  |  |
| 2724 | 1131 | **Enhancements on LTE-based V2X Services** |  | 458d? | 2017-03-15 A | 2018-12-14 | 99% | 2.11d? | 1886d |  | R1 | 10472h | 10423.7h | LTE_eV2X | 38 | Huawei |  | Rel-15 | 75 |  |  |
| 2725 | 1131.1 | Core part: V2X phase 2 based on LTE |  | 393d? | 2017-03-15 A | 2018-09-14 | 99% | 3.93d? | 1951d | finish no earlier than 2018-09-15 | R1 | 3144h | 3112.56h | LTE_eV2X-Core | 38 | Huawei |  | Rel-15 | 75 | 36.788 | RP-180858 |
| 2726 | 1131.2 | Perf. Part: V2X phase 2 based on LTE |  | 458d? | 2017-03-15 A | 2018-12-14 A | 100% |  |  | finish no earlier than 2018-12-15 | R4 | 3664h | 3664h | LTE_eV2X-Perf | 38 | Huawei |  | Rel-15 | 75 |  |  |
| 2727 | 1132 | Study on security aspects for LTE support of V2X services |  | 465d? | 2015-09-07 A | 2017-06-15 A | 100% |  |  | finish no earlier than 2017-06-15 | S3 | 3720h | 3720h | FS_V2XLTE_ARC | 36 | Huawei, Marcus Wong | mwong@huawei.com | Rel-15 | 70 | 33.885 |  |
| 2728 | 1133 | Release 15 Features on Ultra/Highly Reliable Low Latency Communication | milestone | 0d? | 2016-06-09 A | 2016-06-09 A | 100% |  |  | finish no earlier than 2016-06-09 |  |  |  |  |  |  |  | Rel-15 |  |  |  |
| 2729 | 1134 | EPC support for E-UTRAN Ultra Reliable Low Latency Communication |  | 135d? | 2017-09-08 A | 2018-03-15 A | 100% |  |  | finish no earlier than 2018-03-15 | S2 | 1080h | 1080h | EPS_URLLC | 39 | Chris PUDNEY | chris dot pudney at vodafone dot com | Rel-15 | 77 | 23.401; 23.214; 23.203 |  |
| 2730 | 1135 | **Highly Reliable Low Latency Communication for LTE** |  | 458d? | 2017-03-15 A | 2018-12-15 | 46% | 248.61d? | 1886d |  | R1 | 10472h | 4787.72h | LTE_HRLLC | 38 | Ericsson |  | Rel-15 | 75 |  |  |
| 2731 | 1135.1 | Core part: Highly Reliable Low Latency Communication for LTE |  | 393d? | 2017-03-15 A | 2018-09-14 | 99% | 3.93d? | 1951d | finish no earlier than 2018-09-15 | R1 | 3144h | 3112.56h | LTE_HRLLC-Core | 38 | Ericsson |  | Rel-15 | 75 |  | RP-180693 |
| 2732 | 1135.2 | Perf. part: Highly Reliable Low Latency Communication for LTE |  | 458d? | 2017-03-15 | 2018-12-15 |  |  | 1886d | finish no earlier than 2018-12-15 | R4 | 3664h |  | LTE_HRLLC-Perf | 38 | Ericsson |  | Rel-15 | 75 |  |  |
| 2733 | 1136 | Release 15 Features on improvements of Mission Critical (MC) | milestone | 0d? | 2016-06-09 A | 2016-06-09 A | 100% |  |  | finish no earlier than 2016-06-09 |  |  |  |  |  |  |  | Rel-15 |  |  |  |
| 2734 | 1137 | Study on MC system migration and interconnect between MCPTT systems |  | 262d? | 2016-06-13 A | 2017-06-12 A | 100% |  |  | finish no earlier than 2017-06-12 | S6 | 2096h | 2096h | FS_MCSMI | 37 | Chater-Lea, David |  | Rel-15 | 72 | New 23.781 |  |
| 2735 | 1138 | Study on MC Communication Interworking between LTE and non-LTE Systems |  | 262d? | 2016-06-13 A | 2017-06-12 A | 100% |  |  | finish no earlier than 2017-06-12 | S6 | 2096h | 2096h | FS_MCCI | 37 | Monnes, Peter (Harris Corp.) |  | Rel-15 | 72 | New 23.782 |  |
| 2736 | 1139 | Study on MC Security Enhancements |  | 456d? | 2016-06-17 A | 2018-03-15 A | 100% |  |  | finish no earlier than 2018-03-15 | S3 | 3648h | 3648h | FS_MC_Sec | 37 | Haigh, Peter, CESG | peter.haigh@cesg.gsi.gov.uk | Rel-15 | 72 | 33.xxx; 33.280; 39.880 |  |
| 2737 | 1140 | MC Communication Interworking between LTE and non-LTE Systems (Stage 3 in Rel16) |  | 139d? | 2017-06-05 A | 2017-12-14 A | 100% |  |  | start no earlier than 2017-06-05 | S6 | 1112h | 1112h | MCCI | 39 | Monnes, Peter, Harris Corporation | pmonnes at harris dot com | Rel-15 | 76 | New 23.283; 23.280; 23.379; 23.282 |  |
| 2738 | 1141 | Removal of 'over LTE' limitation from Mission Critical Specifications |  | 23d? | 2017-11-15 A | 2017-12-15 A | 100% |  |  | finish no earlier than 2017-12-15 | S1 | 184h | 184h | MCOver | 40 | Kees Verweij ;The Police of the Netherlands | KeesdotVerweijatPolitiedotNL | Rel-15 | 78 | 22.179; 22.280; 22.281; 22.282; 22.468 |  |
| 2739 | 1142 | **Enhancements to MCPTT functional architecture and information flows** |  | 336d? | 2017-03-03 A | 2018-06-15 A | 100% |  |  |  |  | 3248h | 3248h | enhMCPTT | 38 | Dom Lazara, Motorola Solutions | dom.lazara@motorolasolutions.com | Rel-15 | 75 | 23.280 + 23.379 |  |
| 2740 | 1142.1 | Stage 2 of enhMCPTT |  | 205d? | 2017-03-03 A | 2017-12-14 A | 100% |  |  | finish no earlier than 2017-12-14 | S6 | 1640h | 1640h | enhMCPTT | 38 | Dom Lazara, Motorola Solutions | dom.lazara@motorolasolutions.com | Rel-15 | 75 | 23.280 + 23.379 |  |
| 2741 | 1142.2 | Stage 3 of enhMCPTT |  | 201d? | 2017-09-08 A | 2018-06-15 A | 100% |  |  | finish no earlier than 2018-06-15 | C1 | 1608h | 1608h | enhMCPTT-CT | 39 | FREDERICKS, Bob | bobfredericks@motorolasolutions.com | Rel-15 | 77 | 24.379; 24.380; 24.481; 24.482; 24.483; 24.484 |  |
| 2742 | 1143 | **Enhancements to MC Data Functional architecture and information flows** |  | 336d? | 2017-03-03 A | 2018-06-15 A | 100% |  |  |  |  | 3248h | 3248h | eMCData | 38 | David Freeman, Home Office | david@dnf-consulting.co.uk | Rel-15 | 75 | 23.280 + 23.282 |  |
| 2743 | 1143.1 | Stage 2 of eMCData |  | 205d? | 2017-03-03 A | 2017-12-14 A | 100% |  |  | finish no earlier than 2017-12-14 | S6 | 1640h | 1640h | eMCData | 38 | David Freeman, Home Office | david@dnf-consulting.co.uk | Rel-15 | 75 | 23.280 + 23.282 |  |
| 2744 | 1143.2 | Stage 3 of eMCData |  | 201d? | 2017-09-08 A | 2018-06-15 A | 100% |  |  | finish no earlier than 2018-06-15 | C1 | 1608h | 1608h | eMCData-CT | 39 | HASON, Baruh | Baruh.Hason@motorolasolutions.com | Rel-15 | 77 | 24.282; 24.582; 24.481; 24.483; 24.484 |  |

Notes:
- 2720: 19/9/16: 30%->70¦6/10/16: 22.886 added¦1/12/16: 70%->95¦2/3/17: 95%->100
- 2721: 7/6/17: 90%->100
- 2722: no Perf. part¦12/7/17: 36.787 added;
- 2723: no Perf. part¦19/6/17: Compl:0%->20%¦19/9/17: Compl:20%->40%¦8/1/18: Compl:40%->50%¦27/3/18: Compl:50%->70%;
- 2724: follow-up WI of REL-14 WI LTE_V2X for which the Core part was completed at RAN #75¦14/9/17: WID:RP-170798->RP-171069
- 2725: follow-up WI of REL-14 WI LTE_V2X for which the Core part was completed at RAN #75¦19/6/17: Compl:0%->15%¦ 30/6/17: 36.788 added;¦19/9/17: Compl:15%->30% 8/1/18: Compl:30%->55%27/3/18: Compl:55%->75%
- 2726: follow-up WI of REL-14 WI LTE_V2X for which the Core part was completed at RAN #7519/6/17: WID: RP-170798->RP-17106919/9/17: WID: RP-171069->RP-171740¦27/6/18: Compl:0%->5%¦16/1/19: 5%->100¦16/1/19: WID:RP-171740->RP-182549
- 2727: 11/12/15: WID:SP-150715->SP-150743. 28/01/16: typo on name corrected, WD corrected (was SP-150743)¦7/3/16: 0%->10¦19/9/16: 10%->65¦1/12/16: 65%->85¦6/3/17: 85%->90¦21/3/17: FCD shifted, moved from Rel-14¦21/3/17: FCD:09/16->06/17¦8/8/18: 90%->100
- 2728: -
- 2729: 15/12/17: WID:SP-170797->SP-170811¦15/12/17: 0%->15¦20/3/18: 15%->100
- 2730: 14/9/17: WID:RP-170796->RP-171489
- 2731: ¦19/6/17: WID: RP-170796->RP-171489¦8/1/18: Compl:0%->10%¦8/1/18: WID: RP-171489->RP-172845¦27/3/18: Compl:10%->30%¦27/6/18: Compl:30%->99%¦27/6/18: CD:Fri 15
- 2732: ¦19/6/17: WID: RP-170796->RP-171489¦8/1/18: WID: RP-171489->RP-172845¦27/6/18: WID: RP-172845->RP-181259
- 2733: -
- 2734: 28/7/16: 23.781 added¦19/9/16: WID:SP-160340->SP-160526¦FCD: 09/16->12/16¦19/9/16: 0%->40¦1/12/16: WID:SP-160526->SP-160880¦1/12/16: 40%->48¦9/12/16: FCD:12/16->06/17, Rel-14->Rel-15¦3/3/17: 48%->60¦7/6/17: 60%->100
- 2735: 28/7/16: 23.782 added¦19/9/16: WID:SP-160341->SP-160527¦19/9/16: 0%->20¦1/12/16: WID:SP-160527->SP-160881¦1/12/16: 20%->22¦9/12/16: FCD:12/16->06/17, Rel-14->Rel-15¦3/3/17: 22%->50¦7/6/17: 50%->90¦11/9/17: 90%->100
- 2736: 28/7/16: 33.280 added¦28/7/16: 39.880 added¦19/9/16: WID:SP-160374->SP-160567. FCD: 12/16->03/17¦1/12/16: 0%->35¦6/3/17: FCD:03/17->06/17¦6/3/17: 35%->60¦7/6/17: FCD:06/17->12/17 (Rel-14->Rel-15);60%->65¦8/6/17: WID:SP-160567->SP-170416¦11/9/17
- 2737: 11/9/17: 0%->40¦15/12/17: 40%->87¦16/3/18: 87%->100. 10/9/18: moved from Rel-15 since too late for St 3 in Rel-15 as said in CT81. 12/9/18: moved back to Rel-15, while St.3 will be Rel-16
- 2738: 7/6/18: WID:SP-170986->SP-180354
- 2739: 21/3/17: impacted TS/TR added¦7/6/17: 0%->25
- 2740: 21/3/17: impacted TS/TR added¦7/6/17: 0%->25¦11/9/17: 25%->45¦15/12/17: 45%->100
- 2741: 15/12/17: 0%->10¦7/6/18: 10%->20¦10/9/18: 20%->80¦7/12/18: 80%->85¦10/12/18: 85%->100
- 2742: 21/3/17: impacted TS/TR added¦7/6/17: 0%->10¦8/6/17: WID:SP-170249->SP-170462
- 2743: 21/3/17: impacted TS/TR added¦7/6/17: 0%->10¦8/6/17: WID:SP-170249->SP-170462¦11/9/17: 10%->15¦15/12/17: 15%->100
- 2744: 20/3/18: 0%->30¦7/6/18: 30%->85¦10/12/18: 85%->100

| ID | WBS | Task | Type | Duration | Start | Finish | Complete | Remaining | Total slack | Constraint | Resources | Work | Actual work | Acronym | PCG approved | Impacted TSs and TRs | WI rapporteur name | WI rapporteur e-mail | Release | TSG approved | Status Report |
| --- | --- | --- | --- | --- | --- | --- | --- | --- | --- | --- | --- | --- | --- | --- | --- | --- | --- | --- | --- | --- | --- |
| 2745 | 1144 | **Enhancements to MC Video Functional architecture and information flows** |  | 270d? | 2017-06-05 A | 2018-06-15 A | 100% |  |  |  |  | 6042.8h | 6042.8h | eMCVideo | 39 | 23.280; 23.281 | Niranth Amogh, Huawei Telecommunications (India | namogh@huawei.com | Rel-15 | 76 |  |
| 2746 | 1144.1 | Stage 2 of eMCVideo |  | 139d? | 2017-06-05 A | 2017-12-14 A | 100% |  |  | finish no earlier than 2017-12-14 | S6 | 1112h | 1112h | eMCVideo | 39 | 23.280; 23.281 | Niranth Amogh, Huawei Telecommunications (India | namogh@huawei.com | Rel-15 | 76 |  |
| 2747 | 1144.2 | **Stage 3 of eMCVideo** |  | 201d? | 2017-09-08 A | 2018-06-15 A | 100% |  |  |  | ct | 4930.8h | 4930.8h | eMCVideo-CT | 39 |  | WEI, Haitao | weihaitao@huawei.com | Rel-15 | 77 |  |
| 2748 | 1144.2.1 | CT1 aspects of eMCVideo |  | 138.45d? | 2017-09-08 A | 2018-06-15 A | 100% |  |  | finish no earlier than 2018-06-15 | C1 | 1107.6h | 1107.6h | eMCVideo-CT | 39 | 24.281; 24.581; 24.481; 24.483; 24.484 | WEI, Haitao | weihaitao@huawei.com | Rel-15 | 77 |  |
| 2749 | 1144.2.2 | CT3 aspects of eMCVideo |  | 138.45d? | 2017-12-05 A | 2018-06-15 A | 100% |  |  | finish no earlier than 2018-06-15 | C3 | 1107.6h | 1107.6h | eMCVideo-CT | 39 | 29.165; 29.213; 29.214 | WEI, Haitao | weihaitao@huawei.com | Rel-15 | 77 |  |
| 2750 | 1144.2.3 | CT6 aspects of eMCVideo |  | 138.45d? | 2017-12-05 A | 2018-06-15 A | 100% |  |  | finish no earlier than 2018-06-15 | C6 | 1107.6h | 1107.6h | eMCVideo-CT | 39 | 31.102; 31.103 | WEI, Haitao | weihaitao@huawei.com | Rel-15 | 77 |  |
| 2751 | 1145 | MC Security Enhancements |  | 270d? | 2017-06-05 A | 2018-06-15 A | 100% |  |  | finish no earlier than 2018-06-15 | S3 | 2160h | 2160h | eMCSec | 39 | 33.180 | Haigh, Peter, NCSC |  | Rel-15 | 76 |  |
| 2752 | 1146 | **MBMS usage for MC communication services** |  | 330d? | 2017-03-03 A | 2018-06-07 A | 100% |  |  |  | S6 | 4640h | 4640h | MBMS_Mcservices | 38 | 23.280 + 23.281 + 23.282 + 23.379 | Magnus Tränk, Ericsson | magnus.trank@ericsson.com | Rel-15 | 75 |  |
| 2753 | 1146.1 | Stage 2 for MBMS_Mcservices |  | 206d? | 2017-03-03 A | 2017-12-15 A | 100% |  |  | finish no earlier than 2017-12-15 | S6 | 1648h | 1648h | MBMS_Mcservices | 38 | 23.280 + 23.281 + 23.282 + 23.379 | Magnus Tränk, Ericsson | magnus.trank@ericsson.com | Rel-15 | 75 |  |
| 2754 | 1146.2 | Stage 3 for MBMS_Mcservices |  | 44d? | 2018-04-09 A | 2018-06-07 A | 100% |  |  | finish no earlier than 2018-06-07 | C1 | 352h | 352h | MBMS_Mcservices | 41 | 24.281; 24.282; 24.379; 24.380; 24.581; 24.380 | Axell, Jörgen, Ericsson | Jorgen.Axell@ericsson.com | Rel-15 | 80 |  |
| 2755 | 1147 | MC system migration and interconnection |  | 139d? | 2017-06-05 A | 2017-12-14 A | 100% |  |  | start no earlier than 2017-06-05 | S6 | 1112h | 1112h | MCSMI | 39 | 23.280; 23.379; 23.281; 23.282; 24.885 | Chater-Lea, David; Motorola Solutions | david.chater-lea@motorolasolutions.com | Rel-15 | 76 |  |
| 2756 | 1148 | Protocol enhancements for Mission Critical Services |  | 201d? | 2017-09-08 A | 2018-06-15 A | 100% |  |  | finish no earlier than 2018-06-15 | C1 | 1608h | 1608h | MCProtoc15 | 39 |  | Jörgen Axell |  | Rel-15 | 77 |  |
| 2757 | 1149 | UE Conformance Test Aspects - Enhancements for Mission Critical Services MCPTT, MCData and MCVideo |  | 460d | 2020-09-17 A | 2022-06-22 A | 100% |  |  | finish no earlier than 2022-06-22 | R5 | 3680h | 3680h | MCenhUEConTest | 45 |  | KAHN, Jason, NIST (U.S. Department of Commerce) | jason.kahn@nist.gov | Rel-15 | 89 | RP-221332 |
| 2758 | 1150 | Release 15 Features on MTC-IoT | milestone | 0d? | 2016-06-09 A | 2016-06-09 A | 100% |  |  | finish no earlier than 2016-06-09 |  |  |  |  |  |  |  |  | Rel-15 |  |  |
| 2759 | 1151 | Battery Efficient Security for very low Throughput MTC Devices |  | 389d? | 2016-09-19 A | 2018-03-15 A | 100% |  |  | finish no earlier than 2018-03-15 | S3 | 3112h | 3112h | BEST_MTC_Sec | 37 | 33.401; 43.020; 33.220; 33.163 | Evans, Tim, VODAFONE Group Plc. |  | Rel-15 | 73 |  |
| 2760 | 1152 | AT Commands for CIoT-Ext |  | 130d? | 2017-12-15 A | 2018-06-14 A | 100% |  |  | finish no earlier than 2018-06-14 | C1 | 1040h | 1040h | AT_CIoT-Ext | 40 | 27.007 | Bakker, John-Luc (Blackberry) | jbakker@blackberry.com | Rel-15 | 78 |  |
| 2761 | 1153 | **Even further enhanced MTC for LTE** |  | 1246d? | 2017-03-15 A | 2021-12-21 A | 100% |  |  |  | R1 | 20984h | 20984h | LTE_eMTC4 | 38 |  | Ericsson |  | Rel-15 | 75 |  |
| 2762 | 1153.1 | Core part: Even further enhanced MTC for LTE |  | 393d? | 2017-03-15 A | 2018-09-14 A | 100% |  |  | finish no earlier than 2018-09-15 | R1 | 3144h | 3144h | LTE_eMTC4-Core | 38 |  | Ericsson |  | Rel-15 | 75 | RP-181213 |
| 2763 | 1153.2 | Perf. part: Even further enhanced MTC for LTE |  | 458d? | 2017-03-15 A | 2018-12-14 A | 100% |  |  | finish no earlier than 2018-12-15 | R4 | 3664h | 3664h | LTE_eMTC4-Perf | 38 |  | Ericsson |  | Rel-15 | 75 |  |
| 2764 | 1153.3 | UE Conformance Test Aspects - Even further enhanced MTC for LTE |  | 527d | 2019-12-16 A | 2021-12-21 A | 100% |  |  | finish no earlier than 2021-12-21 | R5 | 4216h | 4216h | LTE_eMTC4-UEConTest | 44 |  | Ericsson |  | Rel-15 | 86 | RP-211862 |
| 2765 | 1154 | **Further NB-IoT enhancements** |  | 1171d? | 2017-03-15 A | 2021-09-08 | 98% | 17.62d? | 1173d |  | R1 | 19816h | 13870.2h | NB_IOTenh2 | 38 |  | Huawei |  | Rel-15 | 75 |  |
| 2766 | 1154.1 | Core part: Further NB-IoT enhancements |  | 393d? | 2017-03-15 A | 2018-09-14 | 95% | 19.65d? | 1951d | finish no earlier than 2018-09-15 | R1 | 3144h | 2986.8h | NB_IOTenh2-Core | 38 |  | Huawei |  | Rel-15 | 75 | RP-180851 |
| 2767 | 1154.2 | Perf. part: Further NB-IoT enhancements |  | 458d? | 2017-03-15 A | 2018-12-14 A | 100% |  |  | finish no earlier than 2018-12-15 | R4 | 3664h | 3664h | NB_IOTenh2-Perf | 38 |  | Huawei |  | Rel-15 | 75 |  |
| 2768 | 1154.3 | UE Conformance Test Aspects - Further NB-IoT enhancements |  | 455d | 2019-12-12 A | 2021-09-08 A | 100% |  |  | finish no earlier than 2021-09-08 | R5 | 3640h | 3640h | NB_IOTenh2-UEConTest | 44 |  |  |  | Rel-15 | 86 |  |
| 2769 | 1155 | Release 15 Features related to WLAN | milestone | 0d? | 2016-06-09 A | 2016-06-09 A | 100% |  |  | finish no earlier than 2016-06-09 |  |  |  |  |  |  |  |  | Rel-15 |  |  |

Notes:
- 2745: 7/6/17: 0%->10
- 2746: 7/6/17: 0%->10¦11/9/17: 10%->60¦15/12/17: 60%->100
- 2747: 7/6/18: WID:CP-172032->CP-181084
- 2748: 20/3/18: 0%->25¦7/6/18: 25%->100¦12/6/18: 100%->99¦10/9/18: 99%->100
- 2749: 10/9/18: 0%->100
- 2750: 10/9/18: 0%->100
- 2751: 15/12/17: 0%->80¦15/12/17: FCD:12/17->03/18¦21/12/17: FCD:03/18->05/18. Exception in SP-171056¦16/3/18: 80%->90¦16/3/18: FCD:05/18->06/18¦7/6/18: 90%->100
- 2752: 21/3/17: impacted TS/TR added¦7/6/17: 0%->45¦8/9/17: WID:SP-170075->SP-170686¦8/9/17: FCD:09/17->12/17¦11/9/17: 45%->70¦15/12/17: 70%->95¦16/3/18: 95%->100. Problem with % complete when set as Parent Feature. Has to be left as independent item…
- 2753: 21/3/17: impacted TS/TR added¦7/6/17: 0%->45¦8/9/17: WID:SP-170075->SP-170686¦8/9/17: FCD:09/17->12/17¦11/9/17: 45%->70¦15/12/17: 70%->95¦16/3/18: 95%->100
- 2754: 12/6/18: 10%->30¦10/9/18: 30%->70¦7/12/18: 70%->100
- 2755: 12/7/17: WID:SP-170402->SP-170577¦11/9/17: 0%->20¦15/12/17: 20%->80¦16/3/18: 80%->100
- 2756: 14/9/17: 0%->15¦15/12/17: 15%->40¦20/3/18: 40%->70¦7/6/18: 70%->100
- 2757: tested: REL-15 SA/CT WIs enhMCPTT, eMCVideo, eMCData, MBMS_Mcservices, MCSMI, MCProtoc15, MCOver ; 8/4/21: 0%->16; 2/7/21: 16%->33; 13/9/21: Compl:33%->40%; 13/9/21: CD:Fri 17/12/21->Tue 21/12/21; 13/9/21: Stat Rep: ->RP-211764; 6/1/22: WID:RP-201487- ; 20/6/22: Rapporteur: NIST->KAHN, Jason, NIST (U.S. Department of Commerce); Rap eMail: ->jason.kahn@nist.gov;
- 2758: -
- 2759: 6/10/16: 33.163 added 6/3/17: FCD:12/16->09/17¦6/3/17: 0%->20. Moved from Rel-14.¦7/6/17: 20%->95¦15/12/17: FCD:09/17->03/18¦16/3/18: 95%->100
- 2760: 20/3/18: 0%->20¦7/6/18: 20%->100
- 2761: WI LTE_feMTC-Core got a 3 months exception granted by RAN #75 to complete in REL-14¦note: RAN #75 approved WID RP-170732 with working agreement¦14/9/17: WID:RP-170732->RP-171427
- 2762: WI LTE_feMTC-Core got a 3 months exception granted by RAN #75 to complete in REL-14¦note: RAN #75 approved WID RP-170732 with working agreement¦19/6/17: Compl:0%- 19/9/ 8/1 2 ;¦16/1/19: 97%->100
- 2763: note: RAN #75 approved WID RP-170732 with working agreement19/6/17: WID: RP-170732->RP-171427¦8/1/18: WID: RP-171427->RP-172811¦27/6/18: Compl:0%->50%¦16/1/19: 50%->100
- 2764: affects: LTE. tested: REL-15 WI LTE_eMTC4-Core; 8/10/20: 0%->47; 8/4/21: 47%->54; 8/4/21: FCD:15/12/2020->06/21; 2/7/21: FCD:Fri 11/06/->12/21; 2/7/21: 54%->77; 13/9/21: Compl:77%->80%; ; 6/1/22: 80%->100
- 2765: follow-up WI of REL-14 WI NB_IOTenh which got an exception granted at RAN #75 to complete by RAN #76¦note: RAN #75 approved WID RP-170852 with working agreement¦14/9/17: WID:RP-170852->RP-171428
- 2766: follow-up WI of REL-14 WI NB_IOTenh which got an exception granted at RAN #75 to complete by RAN #76¦note: RAN #75 approved WID RP-170852 with working agreement;1 8/1/12 ;
- 2767: follow-up WI of REL-14 WI NB_IOTenh which got an exception granted at RAN #75 to complete by RAN #76¦note: RAN #75 approved WID RP-170852 with working agreement¦8/1 ;¦26/3/19: 30%->100
- 2768: 8/10/20: 0%->25; 8/10/20: FCD:11/12/2020->12/20; 8/4/21: 25%->79; 8/4/21: FCD:11/12/2020->06/21; 2/7/21: FCD:Fri 11/06/->09/21; 2/7/21: 79%->93; 29/9/21: 93%->100
- 2769: -

| ID | WBS | Task | Type | Duration | Start | Finish | Complete | Constraint | Resources | Work | Actual work | Acronym | PCG approved | Impacted TSs and TRs | WI rapporteur name | WI rapporteur e-mail | Release | TSG approved |
| --- | --- | --- | --- | --- | --- | --- | --- | --- | --- | --- | --- | --- | --- | --- | --- | --- | --- | --- |
| 2770 | 1156 | **Inclusion of WLAN direct discovery technologies as an alternative for ProSe direct discovery** |  | 348d? | 2016-11-15 A | 2018-03-15 A | 100% |  |  | 4528h | 4528h | ProSe_WLAN_DD | 38 | 22.278 | Intel Corporation; Ana Lucia Pinheiro | ana.lucia.a.pinheiro@intel.com | Rel-15 | 74 |
| 2771 | 1156.1 | Stage 1 of ProSe_WLAN_DD |  | 23d? | 2016-11-15 A | 2016-12-15 A | 100% | finish no earlier than 2016-12-15 | S1 | 184h | 184h | ProSe_WLAN_DD | 38 | 22.278 | Intel Corporation; Ana Lucia Pinheiro | ana.lucia.a.pinheiro@intel.com | Rel-15 | 74 |
| 2772 | 1156.2 | Stage 2 of ProSe_WLAN_DD |  | 76d? | 2017-03-02 A | 2017-06-15 A | 100% | finish no earlier than 2017-06-15 | S2 | 608h | 608h | ProSe_WLAN_DD_Stage2 | 38 |  | Intel, Sašo Stojanovski | saso.stojanovski@intel.com | Rel-15 | 75 |
| 2773 | 1156.3 | **Stage 3 of ProSe_WLAN_DD** |  | 134d? | 2017-06-02 A | 2017-12-06 A | 100% |  | ct | 3216h | 3216h | ProSe_WLAN_DD_Stage3 | 39 |  | Intel, Vivek Gupta | vivek.g.gupta@intel.com | Rel-15 | 76 |
| 2774 | 1156.3.1 | CT1 aspects of ProSe_WLAN_DD |  | 134d? | 2017-06-02 A | 2017-12-06 A | 100% | finish no earlier than 2017-12-06 | C1 | 1072h | 1072h | ProSe_WLAN_DD_Stage3 | 39 | 24.334 | Intel, Vivek Gupta | vivek.g.gupta@intel.com | Rel-15 | 76 |
| 2775 | 1156.3.2 | CT4 aspects of ProSe_WLAN_DD |  | 134d? | 2017-06-02 A | 2017-12-06 A | 100% | finish no earlier than 2017-12-06 | C4 | 1072h | 1072h | ProSe_WLAN_DD_Stage3 | 39 | 29.345; 29.230; 23.008 | Intel, Vivek Gupta | vivek.g.gupta@intel.com | Rel-15 | 76 |
| 2776 | 1156.4 | Charging of ProSe_WLAN_DD |  | 65d? | 2017-12-15 A | 2018-03-15 A | 100% | finish no earlier than 2018-03-15 | S5 | 520h | 520h | ProSe_WLAN_DD-CH | 38 | 32.277; 32.298; 32.299 | Yizhi Yao, Intel Corporation | yizhi.yao@intel.com | Rel-15 | 74 |
| 2777 | 1157 | **Complementary Features for Voice services over WLAN** |  | 525d? | 2016-06-13 A | 2018-06-14 A | 100% |  |  | 10416h | 10416h | VoWLAN | 39 |  |  |  | Rel-15 | 76 |
| 2778 | 1157.1 | Study on Complementary Features for Voice services over WLAN |  | 199d? | 2016-06-13 A | 2017-03-15 A | 100% | finish no earlier than 2017-03-15 | S2 | 1592h | 1592h | FS_VoWLAN | 37 | 23.751 | Nokia (Nicolas Drevon | nicolas.drevon@nokia.com | Rel-15 | 72 |
| 2779 | 1157.2 | Stage 2 of VoWLAN |  | 23d? | 2017-05-09 A | 2017-06-08 A | 100% | finish no earlier than 2017-06-08 | S2 | 184h | 184h | VoWLAN | 39 | 23.402 | Drevon Nicolas, Nokia | nicolas.drevon@nokia.com | Rel-15 | 76 |
| 2780 | 1157.3 | **CT aspects of VoWLAN** |  | 270d? | 2017-06-02 A | 2018-06-14 A | 100% |  | ct | 8640h | 8640h | VoWLAN-CT | 39 |  | Jennifer Liu (Nokia) | Jennifer.Liu at nokia.com | Rel-15 | 76 |
| 2781 | 1157.3.1 | CT1 aspects of VoWLAN |  | 270d? | 2017-06-02 A | 2018-06-14 A | 100% | finish no earlier than 2018-06-14 | C1 | 2160h | 2160h | VoWLAN-CT | 39 | 24.302 ; 24.312 ; 24.244 | Jennifer Liu (Nokia) | Jennifer.Liu at nokia.com | Rel-15 | 76 |
| 2782 | 1157.3.2 | CT4 aspects of VoWLAN |  | 270d? | 2017-06-02 A | 2018-06-14 A | 100% | finish no earlier than 2018-06-14 | C4 | 2160h | 2160h | VoWLAN-CT | 39 | 29.274 | Jennifer Liu (Nokia) | Jennifer.Liu at nokia.com | Rel-15 | 76 |
| 2783 | 1157.3.3 | CT6 aspects of VoWLAN |  | 270d? | 2017-06-02 A | 2018-06-14 A | 100% | finish no earlier than 2018-06-14 | C6 | 2160h | 2160h | VoWLAN-CT | 39 | 31.102 | Jennifer Liu (Nokia) | Jennifer.Liu at nokia.com | Rel-15 | 76 |
| 2784 | 1158 | Release 15 Features on Virtual Reality (VR) | milestone | 0d? | 2016-03-01 A | 2016-03-01 A | 100% |  |  |  |  |  |  |  |  |  | Rel-15 |  |
| 2785 | 1159 | Study on Virtual Reality |  | 402d? | 2016-03-01 A | 2017-09-12 A | 100% | finish no earlier than 2017-09-12 | S4 | 3216h | 3216h | FS_VR | 36 | 26.918 | Gilles TENIOU, Orange | gilles.teniou@orange.com | Rel-15 | 71 |
| 2786 | 1160 | Study on 3GPP codecs for VR audio |  | 71d? | 2017-09-08 A | 2017-12-15 A | 100% | finish no earlier than 2017-12-15 | S4 | 568h | 568h | FS_CODVRA | 39 | 26.918 | Toftgård, Tomas, Ericsson | tomas.toftgard@ericsson.com | Rel-15 | 77 |
| 2787 | 1161 | Test Methodologies for the Evaluation of Perceived Listening Quality in Immersive Audio Systems |  | 266d? | 2017-09-08 A | 2018-09-14 A | 100% | finish no earlier than 2018-09-14 | S4 | 2128h | 2128h | LiQuImAS | 39 | New; 26.861; 26.261; 26.260; 26.259 | Schevciw, Andre – Qualcomm Incorporated | aschevci@qti.qualcomm.com | Rel-15 | 77 |
| 2788 | 1162 | Addition of HDR to TV Video Profiles |  | 71d? | 2017-09-08 A | 2017-12-15 A | 100% | finish no earlier than 2017-12-15 | S4 | 568h | 568h | HDR | 39 | 26.116; 26.346; 26.234; 26.247; 26.244 | Thomas Stockhammer, Qualcomm Incorporated | tsto@qti.qualcomm.com | Rel-15 | 77 |
| 2789 | 1163 | Virtual Reality Profiles for Streaming Media |  | 266d? | 2017-09-08 A | 2018-09-14 A | 100% | finish no earlier than 2018-09-14 | S4 | 2128h | 2128h | VRStream | 39 | 26.118; 26.818; 26.247; 26.346; 26.234 | Thomas Stockhammer, Qualcomm Incorporated | tsto@qti.qualcomm.com | Rel-15 | 77 |
| 2790 | 1164 | Release 15 other Features | milestone | 0d? | 2016-06-09 A | 2016-06-09 A | 100% |  |  |  |  |  |  |  |  |  | Rel-15 |  |
| 2791 | 1165 | Forward compatibility for 3GPP Diameter Charging Applications |  | 67d? | 2018-03-15 A | 2018-06-15 A | 100% | finish no earlier than 2018-06-15 | S5 | 536h | 536h | FWDCA | 40 | 32.251; 32.277; 32.299 | Gardella, Maryse, Nokia | maryse.gardella@nokia.com | Rel-15 | 79 |
| 2792 | 1166 | Diameter Overload Control Mechanisms for Charging |  | 132d? | 2018-03-15 A | 2018-09-14 A | 100% | finish no earlier than 2018-09-14 | S5 | 1056h | 1056h | DOCME_CH | 40 | 32.299 | Törnkvist, Robert, Ericsson | robert(dot)tornkvist(at)Ericsson(dot)com | Rel-15 | 79 |
| 2793 | 1167 | Charging aspects of WLAN access in EPC |  | 67d? | 2018-03-15 A | 2018-06-15 A | 100% | start no earlier than 2018-03-15 | S5 | 536h | 536h | WAEPC_CH | 40 | 32.251; 32.260; 32.299; 32.298 | Gardella, Maryse, Nokia | maryse.gardella@nokia.com | Rel-15 | 79 |
| 2794 | 1168 | FEC and ROHC Activation for GCSE over MBMS |  | 132d? | 2018-03-15 A | 2018-09-14 A | 100% | finish no earlier than 2018-09-14 | S4 | 1056h | 1056h | FRASE | 40 | 26.346; new | Bouazizi, Imed, Samsung Electronics Co., Ltd | i.bouazizi@samsung.com. | Rel-15 | 79 |
| 2795 | 1169 | Media Handling Aspects of 5G Conversational Services |  | 132d? | 2018-03-15 A | 2018-09-14 A | 100% | finish no earlier than 2018-09-14 | S4 | 1056h | 1056h | 5G_MTSI_Codecs | 40 | 26.114; 26.223 | Oyman, Ozgur, Company: Intel | ozgur.oyman@intel.com | Rel-15 | 79 |

Notes:
- 2770: 1/12/16: 0%->100
- 2771: 1/12/16: 0%->100
- 2772: 6/3/17: 0%->55¦7/6/17: 55%->100
- 2773: 18/12/17: WID:CP-171102->CP-173084
- 2774: 14/9/17: 0%->60¦15/12/17: 60%->100
- 2775: 15/12/17: 0%->100
- 2776: 15/12/17: 0%->40¦16/3/18: 40%->100
- 2778: 28/7/16: 23.751 added¦19/9/16: 0%->10., 7/12/16: moved from Rel-14, according to SP-160806¦6/3/17: 10%->80¦7/6/17: 80%->100
- 2779: 15/12/17: 0%->100
- 2780: 7/6/18: WID:CP-171101->CP-181083
- 2781: 14/9/17: 0%->70¦15/12/17: 70%->100
- 2782: 7/6/18: 0%->100
- 2783: 7/6/18: 0%->100
- 2784: -
- 2785: 11/6/16: 0%->10¦19/9/16: 10%->40, FCD: 12/16->03/17¦1/12/16: FCD:03/17->06/17¦1/12/16: 40%->35¦14/12/16: 35%->45¦14/12/16: FCD:06/17->09/17¦6/3/17: 45%->55¦7/6/17: 55%->70¦11/9/17: 70%->100
- 2786: 15/12/17: 0%->100¦15/12/17: FCD:09/17->12/17
- 2787: 15/12/17: added: 26.861¦26.261¦26.260¦26.259¦15/12/17: 0%->15¦16/3/18: 15%->20¦7/6/18: 20%->35¦7/6/18: FCD:06/18->09/18¦10/9/18: 35%->100
- 2788: 15/12/17: 0%->100
- 2789: 15/12/17: 26.118 added;¦15/12/17: 0%->25¦16/3/18: 25%->40¦7/6/18: 40%->60¦7/6/18: FCD:06/18->09/18¦10/9/18: 60%->100¦2/10/18: WID:SP-170612->SP-180893
- 2790: -
- 2791: 7/6/18: 0%->100
- 2792: 7/6/18: 0%->10¦7/6/18: FCD:06/18->09/18¦10/9/18: 10%->100
- 2793: 7/6/18: 0%->100
- 2794: 7/6/18: 0%->30¦7/6/18: FCD:06/18->09/18¦10/9/18: 30%->100
- 2795: 7/6/18: 0%->60¦7/6/18: FCD:06/18->09/18¦10/9/18: 60%->100¦2/10/18: WID:SP-180033->SP-180650

| ID | WBS | Task | Duration | Start | Finish | Complete | Remaining | Total slack | Constraint | Resources | Work | Actual work | Acronym | PCG approved | WI rapporteur name | WI rapporteur e-mail | Release | TSG approved | Impacted TSs and TRs | Status Report |
| --- | --- | --- | --- | --- | --- | --- | --- | --- | --- | --- | --- | --- | --- | --- | --- | --- | --- | --- | --- | --- |
| 2796 | 1170 | **SRVCC for terminating call in pre-alerting phase** | 66d? | 2018-03-15 A | 2018-06-14 A | 100% |  |  |  |  | 1056h | 1056h | bSRVCC_MT | 40 | Song Yue (China Mobile) | songyue (at) chinamobile (dot) com | Rel-15 | 79 |  |  |
| 2797 | 1170.1 | CT1 aspects of bSRVCC_MT | 66d? | 2018-03-15 A | 2018-06-14 A | 100% |  |  | start no earlier than 2018-03-15 | C1 | 528h | 528h | bSRVCC_MT | 40 | Song Yue (China Mobile) | songyue (at) chinamobile (dot) com | Rel-15 | 79 | 24.237; 24.008 |  |
| 2798 | 1170.2 | CT3 aspects of bSRVCC_MT | 66d? | 2018-03-15 A | 2018-06-14 A | 100% |  |  | start no earlier than 2018-03-15 | C3 | 528h | 528h | bSRVCC_MT | 40 | Song Yue (China Mobile) | songyue (at) chinamobile (dot) com | Rel-15 | 79 | 29.165 |  |
| 2799 | 1171 | **Increasing the number of EPS bearers** | 66d? | 2018-03-16 A | 2018-06-15 A | 100% |  |  |  |  | 2112h | 2112h | INOBEAR | 40 | Andy.Bennett, Samsung | a <dot> bennett <at> Samsung.com | Rel-15 | 78 | 23.401; 23.167 |  |
| 2800 | 1171.1 | Stage 2 of INOBEAR | 66d? | 2018-03-16 A | 2018-06-15 A | 100% |  |  |  | S2 | 528h | 528h | INOBEAR | 40 | Andy.Bennett, Samsung | a <dot> bennett <at> Samsung.com | Rel-15 | 78 | 23.401; 23.167 |  |
| 2801 | 1171.2 | **Stage 3 of INOBEAR** | 66d? | 2018-03-16 A | 2018-06-15 A | 100% |  |  |  | ct | 1584h | 1584h | INOBEAR-CT | 40 | Samsung, Lalith Kumar | lalith.kumar@samsung.com | Rel-15 | 79 |  |  |
| 2802 | 1171.2.1 | CT1 aspects of INOBEAR | 66d? | 2018-03-16 A | 2018-06-15 A | 100% |  |  | start no earlier than 2018-03-16 | C1 | 528h | 528h | INOBEAR-CT | 40 | Samsung, Lalith Kumar | lalith.kumar@samsung.com | Rel-15 | 79 | 24.301; 24.007 |  |
| 2803 | 1171.2.2 | CT4 aspects of INOBEAR | 66d? | 2018-03-16 A | 2018-06-15 A | 100% |  |  | start no earlier than 2018-03-16 | C4 | 528h | 528h | INOBEAR-CT | 40 | Samsung, Lalith Kumar | lalith.kumar@samsung.com | Rel-15 | 79 | 29.274 |  |
| 2804 | 1172 | **Increased number of E-UTRAN data bearers** | 196d? | 2017-12-15 A | 2018-09-14 | 99% | 1.96d? | 1951d |  | R2 | 3136h | 3104.65h | INOBEARRAN | 40 | Samsung |  | Rel-15 | 78 |  |  |
| 2805 | 1172.1 | Core part: Increased number of E-UTRAN data bearers | 196d? | 2017-12-15 A | 2018-09-14 | 99% | 1.96d? | 1951d | finish no earlier than 2018-09-15 | R2 | 1568h | 1552.32h | INOBEARRAN-Core | 40 | Samsung |  | Rel-15 | 78 |  |  |
| 2806 | 1173 | **Remote UE access via relay UE** | 600d? | 2016-03-01 A | 2018-06-15 A | 100% |  |  |  |  | 4960h | 4960h | REAR | 36 | Huawei, Laurence Meriau | laurence.meriau@huawei.com | Rel-15 | 71 | 22.278; 22.115 |  |
| 2807 | 1173.1 | Study on architecture enhancements to ProSe UE-to-Network Relay | 206d? | 2016-12-01 A | 2017-09-14 A | 100% |  |  | finish no earlier than 2017-09-14 | S2 | 1648h | 1648h | FS_REAR | 38 | Dario Serafino Tonesi, Huawei | dario.tonesi@huawei.com | Rel-15 | 74 | 23.733 |  |
| 2808 | 1173.2 | Study on security aspects of enhancements to ProSe UE-to-Network Relay | 337d? | 2017-03-02 A | 2018-06-15 A | 100% |  |  | finish no earlier than 2018-06-15 | S3 | 2696h | 2696h | FS_REAR_Sec | 38 |  | lihe2@huawei.com | Rel-15 | 75 |  |  |
| 2809 | 1173.3 | Stage 1 for REAR | 77d? | 2016-03-01 A | 2016-06-15 A | 100% |  |  | finish no earlier than 2016-06-15 | S1 | 616h | 616h | REAR | 36 | Huawei, Laurence Meriau | laurence.meriau@huawei.com | Rel-15 | 71 | 22.278; 22.115 |  |
| 2810 | 1174 | **Enhanced VoLTE performance** | 402d? | 2016-12-01 A | 2018-06-15 A | 100% |  |  |  |  | 5680h | 5680h | eVoLP | 40 |  |  | Rel-15 | 78 |  |  |
| 2811 | 1174.1 | Stage 2 of eVoLP | 47d? | 2017-10-12 A | 2017-12-15 A | 100% |  |  | finish no earlier than 2017-12-15 | S2 | 376h | 376h | eVoLP | 40 | Xiaobo Wu, Huawei | wuxiaobo@ huawei.com | Rel-15 | 78 | 23.401; 23.203 |  |
| 2812 | 1174.2 | **CT aspects on enhanced VoLTE performance** | 130d? | 2017-12-15 A | 2018-06-14 A | 100% |  |  |  |  | 2080h | 2080h | eVoLP-CT | 40 | Yan, Yali, Huawei | yanyali@huawei.com | Rel-15 | 78 |  |  |
| 2813 | 1174.2.1 | CT3 aspects of EvoLP | 130d? | 2017-12-15 A | 2018-06-14 A | 100% |  |  | finish no earlier than 2018-06-14 | C3 | 1040h | 1040h | eVoLP-CT | 40 | Yan, Yali, Huawei | yanyali@huawei.com | Rel-15 | 78 | 29.212; 29.213 |  |
| 2814 | 1174.2.2 | CT4 aspects of EvoLP | 130d? | 2017-12-15 A | 2018-06-14 A | 100% |  |  | finish no earlier than 2018-06-14 | C4 | 1040h | 1040h | eVoLP-CT | 40 | Yan, Yali, Huawei | yanyali@huawei.com | Rel-15 | 78 | 29.274 |  |
| 2815 | 1174.3 | **Study on enhanced VoLTE performance** | 402d? | 2016-12-01 A | 2018-06-15 A | 100% |  |  |  |  | 3224h | 3224h | FS_eVoLP | 38 | Fabrice Plante, Intel | fabrice.m.plante@intel.com | Rel-15 | 74 | 23.759 |  |
| 2816 | 1174.3.1 | S2 aspects of FS_eVoLP | 206d? | 2016-12-01 A | 2017-09-14 A | 100% |  |  | finish no earlier than 2017-09-14 | S2 | 1648h | 1648h | FS_eVoLP | 38 | Xiaobo Wu |  | Rel-15 | 74 | 23.759 |  |
| 2817 | 1174.3.2 | S4 aspects of FS_eVoLP | 197d? | 2017-09-14 A | 2018-06-15 A | 100% |  |  | finish no earlier than 2018-06-15 | S4 | 1576h | 1576h | FS_eVoLP | 39 | Venkatraman, Atti, Qualcomm Incorporated | vatti@qti.qualcomm.com | Rel-15 | 77 | 26.959 |  |
| 2818 | 1175 | **Unlicensed Spectrum Offloading System** | 555d? | 2016-02-01 A | 2018-03-15 A | 100% |  |  |  |  | 2952h | 2952h | USOS | 36 | Edward Hall, Qualcomm Incorporated | edhall@qti.qualcomm.com | Rel-15 | 71 |  | SP-170526 |
| 2819 | 1175.1 | Study on unlicensed spectrum offloading system enhancements | 141d? | 2016-12-01 A | 2017-06-15 A | 100% |  |  | finish no earlier than 2017-06-15 | S2 | 1128h | 1128h | FS_USOS | 38 | Haris Zisimopoulos, Qualcomm Incorporated | harisz@qti.qualcomm.com | Rel-15 | 74 | 23.729 |  |
| 2820 | 1175.2 | Stage 1 of USOS | 22d? | 2016-02-01 A | 2016-03-01 A | 100% |  |  | start no earlier than 2016-02-01 | S1 | 176h | 176h | USOS | 36 | Edward Hall, Qualcomm Incorporated | edhall@qti.qualcomm.com | Rel-15 | 71 | 22.101; 22.115 | SP-170526 |
| 2821 | 1175.3 | Stage 2 of USOS | 71d? | 2017-09-08 A | 2017-12-15 A | 100% |  |  | finish no earlier than 2017-12-15 | S2 | 568h | 568h | USOS | 39 | Haris Zisimopoulos | harisz@qti.qualcomm.com | Rel-15 | 77 | 23.401; 23.203 |  |
| 2822 | 1175.4 | Stage 3 of USOS | 135d? | 2017-09-08 A | 2018-03-15 A | 100% |  |  | finish no earlier than 2018-03-15 | C4 | 1080h | 1080h | USOS-CT | 39 | Lena Chaponniere, Qualcomm Incorporated | lguellec@qti.qualcomm.com | Rel-15 | 77 | 23.008; 29.272; 29.230; 29.002; 29.305; 29.274 |  |

Notes:
- 2797: 16/3/18: 0%->80¦7/6/18: 80%->100
- 2798: 22/3/18: 0%->95¦10/9/18: 95%->100
- 2802: 7/6/18: 0%->100
- 2803: 7/6/18: 0%->100
- 2805: 27/3/18: WID: RP-172835->RP-180569¦27/6/18: Compl:0%->99%¦27/6/18:
- 2806: Previously known as "wearable devices"¦9/6/16: 0%->100¦9/6/16: WID:SP-160231->SP-160371
- 2807: 1/12/16: 0%->5. Study on Stage 2 for REAR. When normative work completed, Stage 1 and Stage 2 shall be in the same release¦6/3/17: 5%->30¦7/6/17: 30%->60¦11/9/17: 60%->95¦15/12/17: 95%->100
- 2808: 7/6/17: 0%->15¦11/9/17: 15%->50¦15/12/17: 50%->79¦16/3/18: 79%->99¦16/3/18: FCD:03/18->06/18¦7/6/18: 99%->100
- 2809: Previously known as "wearable devices"¦9/6/16: 0%->100¦9/6/16: WID:SP-160231->SP-160371¦15/12/17: moved Rel-14->Rel-15
- 2813: 16/3/18: 0%->100
- 2814: 7/6/18: 0%->100
- 2815: 1/12/16: 0%->5¦6/3/17: 5%->50¦7/6/17: 50%->60¦11/9/17: 60%->100
- 2816: 1/12/16: 0%->5¦6/3/17: 5%->50¦7/6/17: 50%->60¦11/9/17: 60%->100¦15/12/17: rapporteur changed
- 2817: 15/12/17: 26.959 added;¦15/12/17: 0%->50¦16/3/18: 50%->75¦16/3/18: FCD:03/18->06/18¦7/6/18: 75%->100
- 2818: 08/09/17: Moved from Rel-14
- 2819: 1/12/16: 0%->10¦6/3/17: 10%->30¦7/6/17: 30%->90¦11/9/17: 90%->100
- 2821: 15/12/17: 0%->100
- 2822: 15/12/17: acronym corrected to USOS-CT as per the approved WID¦18/12/17: 0%->60¦16/3/18: 60%->100

| ID | WBS | Task | Duration | Start | Finish | Complete | Constraint | Resources | Work | Actual work | Acronym | PCG approved | WI rapporteur name | WI rapporteur e-mail | Release | TSG approved | TSG stopped |
| --- | --- | --- | --- | --- | --- | --- | --- | --- | --- | --- | --- | --- | --- | --- | --- | --- | --- |
| 2823 | 1176 | **Mobile Communication System for Railways** | 528d? | 2016-06-09 A | 2018-06-15 A | 100% |  |  | 7440h | 7440h | MONASTERY | 38 | Merkel, Juergen, Nokia | juergen.merkel@nokia.com | Rel-15 | 75 |  |
| 2824 | 1176.1 | Study on Future Railway Mobile Communication System | 267d? | 2016-06-09 A | 2017-06-15 A | 100% | finish no earlier than 2017-06-15 | S1 | 2136h | 2136h | FS_FRMCS | 37 | Merkel, Juergen | Merkel, Juergen - Nokia Networks | Rel-15 | 72 |  |
| 2825 | 1176.2 | Study on Application Architecture for the Future Railway Mobile Communication System (stage 2) | 205d? | 2017-03-03 A | 2017-12-14 A | 100% | finish no earlier than 2017-12-14 | S6 | 1640h | 1640h | FS_FRMCS_ARCH | 38 | Oettl, Martin, Nokia | martin(dot)oettl(at)nokia(dot)com | Rel-15 | 75 |  |
| 2826 | 1176.3 | Stage 1 of MONASTERY | 76d? | 2017-03-02 A | 2017-06-15 A | 100% | finish no earlier than 2017-06-15 | S1 | 608h | 608h | MONASTERY | 38 | Merkel, Juergen, Nokia | juergen.merkel@nokia.com | Rel-15 | 75 |  |
| 2827 | 1176.4 | Stage 2 of MONASTERY | 71d? | 2017-09-08 A | 2017-12-15 A | 100% | finish no earlier than 2017-12-15 | S6 | 568h | 568h | MONASTERY | 39 | Oettl, Martin, Nokia | martin(dot)oettl(at)nokia(dot)com | Rel-15 | 77 |  |
| 2828 | 1176.5 | **Stage 3 of MONASTERY** | 66d? | 2018-03-16 A | 2018-06-15 A | 100% |  | ct | 2112h | 2112h | MONASTERY | 40 | Leis, Peter (Nokia) | peter(dot)leis(at)nokia(dot)com | Rel-15 | 79 |  |
| 2829 | 1176.5.1 | CT1 aspects of MONASTERY | 66d? | 2018-03-16 A | 2018-06-15 A | 100% | finish no earlier than 2018-06-15 | C1 | 528h | 528h | MONASTERY | 40 | Leis, Peter (Nokia) | peter(dot)leis(at)nokia(dot)com | Rel-15 | 79 |  |
| 2830 | 1176.5.2 | CT3 aspects of MONASTERY | 66d? | 2018-03-16 A | 2018-06-15 A | 100% | finish no earlier than 2018-06-15 | C3 | 528h | 528h | MONASTERY | 40 | Leis, Peter (Nokia) | peter(dot)leis(at)nokia(dot)com | Rel-15 | 79 |  |
| 2831 | 1176.5.3 | Stopped - CT6 aspects of MONASTERY | 66d? | 2018-03-16 A | 2018-06-15 A | 100% | finish no earlier than 2018-06-15 | C6 | 528h | 528h | MONASTERY | 40 | Leis, Peter (Nokia) | peter(dot)leis(at)nokia(dot)com | Rel-15 | 79 | 84 |
| 2832 | 1176.6 | Security Architecture of MONASTERY | 47d? | 2018-01-11 A | 2018-03-16 A | 100% | finish no earlier than 2018-06-15 | S3 | 376h | 376h | MONASTERY_SEC | 40 | Woodward, Tim, Motorola Solutions |  | Rel-15 | 79 |  |
| 2833 | 1177 | **PS Data Off Phase 2** | 336d? | 2017-03-02 A | 2018-06-14 A | 100% |  |  | 10296h | 10296h | PS_DATA_OFF2 | 38 | Murhammer, Leopold, Deutsche Telekom AG | leopold.murhammer@t-mobile.at | Rel-15 | 75 |  |
| 2834 | 1177.1 | Stage 2 of PS Data Off Phase 2 | 207d? | 2017-03-02 A | 2017-12-15 A | 100% | finish no earlier than 2017-12-15 | S2 | 1656h | 1656h | PS_DATA_OFF2 | 38 | Murhammer, Leopold, Deutsche Telekom AG | leopold.murhammer@t-mobile.at | Rel-15 | 75 |  |
| 2835 | 1177.2 | **Stage 3 of PS Data Off Phase 2** | 270d? | 2017-06-02 A | 2018-06-14 A | 100% |  | ct | 8640h | 8640h | PS_DATA_OFF2-CT | 39 | Herrero Veron, Christian (Huawei) | Christian.Herrero at huawei.com | Rel-15 | 76 |  |
| 2836 | 1177.2.1 | CT1 aspects of PS Data Off Phase 2 | 270d? | 2017-06-02 A | 2018-06-14 A | 100% | finish no earlier than 2018-06-14 | C1 | 2160h | 2160h | PS_DATA_OFF2-CT | 39 | Herrero Veron, Christian (Huawei) | Christian.Herrero at huawei.com | Rel-15 | 76 |  |
| 2837 | 1177.2.2 | CT4 aspects of PS Data Off Phase 2 | 270d? | 2017-06-02 A | 2018-06-14 A | 100% | finish no earlier than 2018-06-14 | C4 | 2160h | 2160h | PS_DATA_OFF2-CT | 39 | Herrero Veron, Christian (Huawei) | Christian.Herrero at huawei.com | Rel-15 | 76 |  |
| 2838 | 1177.2.3 | CT6 aspects of PS Data Off Phase 2 | 270d? | 2017-06-02 A | 2018-06-14 A | 100% | finish no earlier than 2018-06-14 | C6 | 2160h | 2160h | PS_DATA_OFF2-CT | 39 | Herrero Veron, Christian (Huawei) | Christian.Herrero at huawei.com | Rel-15 | 76 |  |
| 2839 | 1178 | **Northbound APIs for SCEF – SCS/AS Interworking** | 337d? | 2017-03-02 A | 2018-06-15 A | 100% |  |  | 10312h | 10312h | NAPS | 38 | Vaidya, Maulik, Huawei | Maulik.vaidya@huawei.com | Rel-15 | 75 |  |
| 2840 | 1178.1 | Stage 2 of NAPS | 142d? | 2017-03-02 A | 2017-09-15 A | 100% | start no earlier than 2017-03-02 | S2 | 1136h | 1136h | NAPS | 38 | Zhu Fenqin, Huawei | zhufenqin@huawei.com | Rel-15 | 75 |  |
| 2841 | 1178.2 | **Stage 3 of NAPS** | 270d? | 2017-06-02 A | 2018-06-14 A | 100% |  | C3 | 6480h | 6480h | NAPS-CT | 40 | Yan, Yali, Huawei, | yanyali@huawei.com | Rel-15 | 78 |  |
| 2842 | 1178.2.1 | CT3 aspects of NAPS | 270d? | 2017-06-02 A | 2018-06-14 A | 100% | finish no earlier than 2018-06-14 | C3 | 2160h | 2160h | NAPS-CT | 39 | Yan, Yali, Huawei, | yanyali@huawei.com | Rel-15 | 76 |  |
| 2843 | 1178.2.2 | CT4 aspects of NAPS | 270d? | 2017-06-02 A | 2018-06-14 A | 100% | finish no earlier than 2018-06-14 | C4 | 2160h | 2160h | NAPS-CT | 40 | Yan, Yali, Huawei, | yanyali@huawei.com | Rel-15 | 78 |  |
| 2844 | 1178.3 | Security aspects of NAPS | 136d? | 2017-09-08 A | 2018-03-16 A | 100% | finish no earlier than 2018-03-16 | S3 | 1088h | 1088h | NAPS-Sec | 39 | Zhao, Xuwen, Huawei | zhaoxuwen@huawei.com | Rel-15 | 77 |  |
| 2845 | 1178.4 | Carging aspects of NAPS | 201d? | 2017-09-08 A | 2018-06-15 A | 100% | finish no earlier than 2018-06-15 | S5 | 1608h | 1608h | NAPS-CH | 39 | Chen, Shan, Huawei | chenshan@huawei.com | Rel-15 | 76 |  |
| 2846 | 1179 | **Common API Framework for 3GPP Northbound APIs** | 331d? | 2017-03-10 A | 2018-06-15 A | 100% |  |  | 3216h | 3216h | CAPIF | 39 | Suresh Chitturi, Samsung | s.chitturi@samsung.com | Rel-15 | 77 |  |
| 2847 | 1179.1 | Study on CAPIF | 135d? | 2017-03-10 A | 2017-09-14 A | 100% | finish no earlier than 2017-09-14 | S6 | 1080h | 1080h | FS_CAPIF | 38 | Suresh Chitturi, Samsung | s.chitturi@samsung.com | Rel-15 | 75 |  |
| 2848 | 1179.2 | Stage 2 of CAPIF | 71d? | 2017-09-08 A | 2017-12-15 A | 100% | finish no earlier than 2017-12-15 | S6 | 568h | 568h | CAPIF | 39 | Suresh Chitturi, Samsung | s.chitturi@samsung.com | Rel-15 | 77 |  |
| 2849 | 1179.3 | Stage 3 of CAPIF | 66d? | 2018-03-16 A | 2018-06-15 A | 100% | finish no earlier than 2018-06-15 | C3 | 528h | 528h | CAPIF-CT | 40 | Nishant Gupta, Samsung | nishant.gup@samsung.com | Rel-15 | 79 |  |
| 2850 | 1179.4 | Security aspects of CAPIF | 130d? | 2017-12-15 A | 2018-06-14 A | 100% | finish no earlier than 2018-06-14 | S3 | 1040h | 1040h | CAPIF-Sec | 40 | Rajavelsamy Rajadurai, Samsung | rajvel{@]samsung.com | Rel-15 | 78 |  |

Notes:
- 2824: 19/9/16: 0%->25¦6/10/16: 22.989 added¦1/12/16: 25%->40¦1/12/16: WID:SP-160371->SP-160903¦9/12/16: FCD:12/16->3/201. WID was in SP-160903¦2/3/17: 40%->80¦2/3/17: FCD:03/17->06/17¦7/6/17: 80%->100 / Impacted TSs and TRs: 22.989
- 2825: 21/3/17: added impacted TR¦7/6/17: 0%->10¦11/9/17: 10%->50¦15/12/17: 50%->100 / Impacted TSs and TRs: new 23.790
- 2826: 7/6/17: 0%->10¦8/9/17: WID:SP-170163->SP-170697¦11/9/17: 10%->100 / Impacted TSs and TRs: 22.280; 22.179
- 2827: 14/9/17: SA6 and not SA2¦15/12/17: 0%->100 / Impacted TSs and TRs: 23.280; 23.379
- 2828: 10/9/18: WID:CP-180097->CP-182202
- 2829: 16/3/18: 0%->40¦7/6/18: 40%->85¦10/9/18: 85%->100 / Impacted TSs and TRs: 24.379; 24.380; 24.481; 24.483; 24.484
- 2830: 10/9/18: 0%->100 / Impacted TSs and TRs: 29.165
- 2831: 10/9/18: 0%->100 / Impacted TSs and TRs: 31.102; 31.103
- 2832: 16/3/18: 0%->100 / Impacted TSs and TRs: 33.180
- 2834: 7/6/17: 0%->10¦11/9/17: 10%->85¦15/12/17: 85%->100¦15/12/17: FCD:09/17->12/17
- 2835: 18/12/17: WID:CP-171104->CP-173162¦7/6/18: WID:CP-173162->CP-181082
- 2836: 7/6/18: 0%->100 / Impacted TSs and TRs: 24.008; 24.301; 27.007; 24.229; 24.368; 24.167; 24.173; 24.275; 24.341; 24.390; 24.391
- 2837: 15/12/17: 0%->100 / Impacted TSs and TRs: 29.272; 29.274; 29.328; 29.329; 29.228; 29.229; 23.008
- 2838: 7/6/18: 0%->100 / Impacted TSs and TRs: 31.102; 31.103; 31.111
- 2839: 6/3/17: 0%->10
- 2840: 6/3/17: 0%->10¦7/6/17: 10%->85¦30/6/17: 29.122 added;¦11/9/17: 85%->100¦15/12/17: rapoprteur changed / Impacted TSs and TRs: 29.122
- 2841: 5/6/17: 0%->25¦8/9/17: WID:CP-171143->CP-172057¦11/9/17: 25%->40¦11/9/17: 40%->90. 18/12/17: WID corrected¦18/12/17: WID:CP-171143 ->CP-173112 / Impacted TSs and TRs: 29.336; 29.128; 29.230
- 2842: 5/6/17: 0%->25¦8/9/17: WID:CP-171143->CP-172057¦11/9/17: 25%->40¦11/9/17: 40%->90¦15/12/17: 90%->65. 18/12/17: WID corrected¦16/3/18: 65%->72¦7/6/18: 72%->85¦7/6/18: 85%->95¦10/9/18: 95%->100 / Impacted TSs and TRs: 29.336; 29.128; 29.230
- 2843: 7/6/18: 95%->100
- 2844: 15/12/17: 0%->60¦16/3/18: 60%->100 / Impacted TSs and TRs: 33.187
- 2845: 30/6/17: 32.254 added;¦11/9/17: 0%->10¦15/12/17: 10%->20¦16/3/18: 20%->50¦7/6/18: 50%->100 / Impacted TSs and TRs: New TS; impact 32.240; 32.298; 32.299; 32.254
- 2846: 15/12/17: 23.222 added; / Impacted TSs and TRs: New; 23.222
- 2847: 21/3/17: added impacted TR¦7/6/17: 0%->35¦8/6/17: WID:SP-170279->SP-170405¦11/9/17: 35%->70¦15/12/17: 70%->100 / Impacted TSs and TRs: new 23.722
- 2848: 15/12/17: 0%->95¦16/3/18: 95%->100 / Impacted TSs and TRs: New
- 2849: 16/3/18: 0%->10¦27/3/18: 29.222 added¦19/4/18: CAPIF->CAPIF-CT¦7/6/18: 10%->35¦7/6/18: 35%->85¦10/9/18: 85%->100 / Impacted TSs and TRs: 29.122; 29.116; 29.222
- 2850: 16/3/18: 0%->40¦7/6/18: 40%->100

| ID | WBS | Task | Duration | Start | Finish | Complete | Constraint | Resources | Work | Actual work | Acronym | PCG approved | WI rapporteur name | WI rapporteur e-mail | Release | TSG approved | Status Report |
| --- | --- | --- | --- | --- | --- | --- | --- | --- | --- | --- | --- | --- | --- | --- | --- | --- | --- |
| 2851 | 1180 | **Management and orchestration of 5G networks and network slicing** | 591d? | 2016-06-13 A | 2018-09-14 A | 100% |  | S5 | 23664h | 23664h | NETSLICE | 39 | Jan Groenendijk, Ericsson | jan<dot>groenendijk<at>ericsson<dot>com | Rel-15 | 76 |  |
| 2852 | 1180.1 | General aspects of NETSLICE | 591d? | 2016-06-13 A | 2018-09-14 A | 100% | finish no earlier than 2018-09-14 | S5 | 4728h | 4728h | NETSLICE | 39 | Jan Groenendijk, Ericsson | jan<dot>groenendijk<at>ericsson<dot>com | Rel-15 | 76 |  |
| 2853 | 1180.2 | Study on management and orchestration of network slicing for next generation network | 328d? | 2016-06-13 A | 2017-09-12 A | 100% | finish no earlier than 2017-09-12 | S5 | 2624h | 2624h | FS_MONETS | 37 | Ericsson , Robert Petersen |  | Rel-15 | 72 |  |
| 2854 | 1180.3 | Study on security aspect of 5G Network Slicing Provisioning | 201d? | 2017-09-08 A | 2018-06-15 A | 100% | finish no earlier than 2018-06-15 | S3 | 1608h | 1608h | FS_NETSLICE_MGT_Sec | 39 | SA3: Huawei | lei.zhongding@huawei.com | Rel-15 | 77 |  |
| 2855 | 1180.4 | Provisioning of network slicing for 5G networks and services | 335d? | 2017-06-05 A | 2018-09-14 A | 100% | finish no earlier than 2018-09-14 | S5 | 2680h | 2680h | NETSLICE-PRO_NS | 39 | Zhang Kai, Huawei | kai.zhangkai@huawei.com | Rel-15 | 76 |  |
| 2856 | 1180.5 | Network Resource Model (NRM) for 5G networks and network slicing | 196d? | 2017-12-15 A | 2018-09-14 A | 100% | finish no earlier than 2018-09-14 | S5 | 1568h | 1568h | NETSLICE-5GNRM | 40 | Nokia (Jing Ping | jing.ping@nokia-sbell.com | Rel-15 | 78 |  |
| 2857 | 1180.6 | Performance Assurance for 5G networks including network slicing | 196d? | 2017-12-15 A | 2018-09-14 A | 100% | finish no earlier than 2018-09-14 | S5 | 1568h | 1568h | NETSLICE-ADPM5G | 40 | Yizhi Yao, Intel Corporation | yizhi dot yao at intel dot com | Rel-15 | 78 |  |
| 2858 | 1180.7 | Management and virtualization aspects of 5G networks | 196d? | 2017-12-15 A | 2018-09-14 A | 100% | finish no earlier than 2018-09-14 | S5 | 1568h | 1568h | NETSLICE-MNFV5G | 40 | Joey Chou, Intel | joey<dot>chou<at>intel<dot>com | Rel-15 | 78 |  |
| 2859 | 1180.8 | 5G Trace management | 125d? | 2017-12-15 A | 2018-06-07 A | 100% | finish no earlier than 2018-06-07 | S5 | 1000h | 1000h | NETSLICE-5GTRACE | 40 | Nokia (Anatoly Andrianov | anatoly.andrianov@nokia.com | Rel-15 | 78 |  |
| 2860 | 1180.9 | **CT aspects of 5G Trace management** | 1d? | 2018-09-06 A | 2018-09-06 A | 100% |  | ct | 24h | 24h | NETSLICE-5GTRACE-CT | 41 | Landais, Bruno, Nokia | bruno.landais@nokia.com | Rel-15 | 81 |  |
| 2861 | 1180.9.1 | CT3 aspects of 5G Trace management | 1d? | 2018-09-06 A | 2018-09-06 A | 100% | start no earlier than 2018-09-06 | C3 | 8h | 8h | NETSLICE-5GTRACE-CT | 41 | Landais, Bruno, Nokia | bruno.landais@nokia.com | Rel-15 | 81 |  |
| 2862 | 1180.9.2 | CT4 aspects of 5G Trace management | 1d? | 2018-09-06 A | 2018-09-06 A | 100% | start no earlier than 2018-09-06 | C4 | 8h | 8h | NETSLICE-5GTRACE-CT | 41 | Landais, Bruno, Nokia | bruno.landais@nokia.com | Rel-15 | 81 |  |
| 2863 | 1180.10 | Fault Supervision for 5G networks and network slicing | 196d? | 2017-12-15 A | 2018-09-14 A | 100% | finish no earlier than 2018-09-14 | S5 | 1568h | 1568h | NETSLICE-FS5G | 40 | Zhu Weihong, ZTE | zhu.weihong@zte.com.cn | Rel-15 | 78 |  |
| 2864 | 1181 | **Policy and Charging for Volume Based Charging** | 402d? | 2016-12-01 A | 2018-06-15 A | 100% |  |  | 7584h | 7584h | PC_VBC | 40 |  |  | Rel-15 | 78 |  |
| 2865 | 1181.1 | **Study on Policy and Charging for Volume Based Charging** | 272d? | 2016-12-01 A | 2017-12-15 A | 100% |  | C3 | 6528h | 6528h | FS_PC_VBC | 38 | Huang, Zhenning, China Mobile | huangzhenning <at> chinamobile <dot> com | Rel-15 | 74 |  |
| 2866 | 1181.1.1 | CT3 aspects of FS_PC_VBC | 272d? | 2016-12-01 A | 2017-12-15 A | 100% | finish no earlier than 2017-12-15 | C3 | 2176h | 2176h | FS_PC_VBC | 38 | Huang, Zhenning, China Mobile | huangzhenning <at> chinamobile <dot> com | Rel-15 | 74 |  |
| 2867 | 1181.1.2 | CT1 aspects of FS_PC_VBC | 272d? | 2016-12-01 A | 2017-12-15 A | 100% | finish no earlier than 2017-12-15 | C1 | 2176h | 2176h | FS_PC_VBC | 38 | Huang, Zhenning, China Mobile | huangzhenning <at> chinamobile <dot> com | Rel-15 | 74 |  |
| 2868 | 1181.2 | CT1 aspects of PV_VBC | 66d? | 2018-03-16 A | 2018-06-15 A | 100% | finish no earlier than 2018-06-15 | C1 | 528h | 528h | PC_VBC | 40 | Huang Zhenning (China Mobile) | huangzhenning (at) chinamobile (dot) com | Rel-15 | 79 |  |
| 2869 | 1181.3 | CT3 aspects of PV_VBC | 66d? | 2018-03-16 A | 2018-06-15 A | 100% | finish no earlier than 2018-06-15 | C3 | 528h | 528h | PC_VBC | 40 | Huang Zhenning (China Mobile) | huangzhenning (at) chinamobile (dot) com | Rel-15 | 79 |  |
| 2870 | 1182 | Framework for Live Uplink Streaming | 269d? | 2017-06-05 A | 2018-06-14 A | 100% | finish no earlier than 2018-06-14 | S4 | 2152h | 2152h | FLUS | 39 | Park, Kyungmo, SK Telecom | kyungmo.park@sk.com | Rel-15 | 76 |  |
| 2871 | 1183 | Self-Organizing Networks (SON) for Active Antenna System (AAS) deployment management | 201d? | 2017-09-08 A | 2018-06-15 A | 100% | finish no earlier than 2018-06-15 | S5 | 1608h | 1608h | OAM_SON_AAS | 39 | Nokia (Weixing Wang) | weixing.wang@nokia-sbell.com | Rel-15 | 77 |  |
| 2872 | 1184 | Server and Network Assisted DASH for 3GPP Multimedia Services | 206d? | 2016-12-01 A | 2017-09-14 A | 100% | finish no earlier than 2017-09-14 | S4 | 1648h | 1648h | SAND | 38 | Ozgur Oyman, Intel | ozgur.oyman@intel.com | Rel-15 | 74 | SP-170687 |
| 2873 | 1185 | SAND for MBMS | 201d? | 2017-09-08 A | 2018-06-15 A | 100% | finish no earlier than 2018-06-15 | S4 | 1608h | 1608h | SAND4M | 39 | Thomas Stockhammer, Qualcomm Incorporated | tsto@qti.qualcomm.com | Rel-15 | 77 |  |
| 2874 | 1186 | Management Enhancement for EPC CUPS | 196d? | 2017-12-15 A | 2018-09-14 A | 100% | finish no earlier than 2018-09-14 | S5 | 1568h | 1568h | ME_CUPS | 40 | Huawei (ZHU, Lei | lei.zhu@huawei.com | Rel-15 | 78 |  |
| 2875 | 1187 | Enhanced QoE Reporting for MTSI | 204d? | 2017-06-05 A | 2018-03-15 A | 100% | finish no earlier than 2018-03-15 | S4 | 1632h | 1632h | EQoE_MTSI | 39 | Gunnar Heikkilä, Ericsson LM | gunnar.heikkila@ericsson.com | Rel-15 | 76 |  |

Notes:
- 2851: 21/12/17: WID:SP-170586->SP-170960. Name changed from "Management of Network Slicing in Mobile Networks, Concepts, Use cases and Requirements"¦27/3/18: 32.159 added;¦6/8/18: 32.159 added;¦8/8/18: WID:SP-170960->SP 180124¦2/10/18: WID:SP 180124->SP- / Impacted TSs and TRs: 32.101; 32.103; new; 32.159; 32.159
- 2852: 21/12/17: created from the Feature level, since SP-170960 contains its own specs and completions¦16/3/18: 46%->60¦7/6/18: 60%->85¦7/6/18: FCD:06/18->09/18¦8/8/18: WID:SP-170960->SP 180124¦10/9/18: 85%->100 / Impacted TSs and TRs: 32.101; 32.103; 28.530
- 2853: 28/7/16: 28.801 added¦19/9/16: 0%->10¦1/12/16: 10%->25¦6/3/17: FCD:03/17->06/17¦6/3/17: 25%->60¦21/3/17: moved from rel-14¦7/6/17: FCD:06/17->09/17¦7/6/17: 60%->90¦11/9/17: 90%->100 / Impacted TSs and TRs: 32.8xx; 28.801
- 2854: 11/9/17: 0%->5¦15/12/17: 33.811 added;¦15/12/17: 5%->20. Acronym corrected.¦16/3/18: 20%->30¦7/6/18: 30%->100 / Impacted TSs and TRs: 33.811
- 2855: 15/12/17: 0%->15¦21/12/17: WID:SP-170580->SP-170955¦16/3/18: 15%->40¦27/3/18: 28.532 added;¦7/6/18: 40%->80¦7/6/18: FCD:06/18->09/18¦10/9/18: 80%->100¦2/10/18: WID:SP-170955->SP-180818 / Impacted TSs and TRs: 28.531
- 2856: 16/3/18: 0%->25¦7/6/18: 25%->60¦7/6/18: FCD:06/18->09/18¦10/9/18: 60%->100¦2/10/18: WID:SP-170956->SP-180812 / Impacted TSs and TRs: 28.657; 28.658; 28.659; 28.707; 28.708; 28.709
- 2857: 16/3/18: 0%->10¦7/6/18: 10%->50¦7/6/18: FCD:06/18->09/18¦10/9/18: 50%->100¦2/10/18: WID:SP-170957->SP-180814 / Impacted TSs and TRs: 32.404
- 2858: 16/3/18: 0%->25¦7/6/18: 25%->75¦7/6/18: FCD:06/18->09/18¦10/9/18: 75%->100 / Impacted TSs and TRs: 28.500; 28.510; 28.511; 28.512; 28.513; 28.515; 28.516; 28.517; 28.518; 28.520; 28.521; 28.522; 28.523; 28.525; 28.526; 28.527; 28.528
- 2859: 7/6/18: 0%->100 / Impacted TSs and TRs: 32.421; 32.422; 32.423; 32.441; 32.442; 32.446
- 2861: 10/9/18: 0%->100 / Impacted TSs and TRs: 29.507; 29.512
- 2862: 10/9/18: 0%->100 / Impacted TSs and TRs: 29.502; 29.503; 29.505; 29.509; 29.518; 29.540; 29.571; 29.244; 29.274
- 2863: 16/3/18: 0%->20¦7/6/18: 20%->60¦7/6/18: FCD:06/18->09/18¦10/9/18: 60%->100¦2/10/18: WID:SP-170961->SP-180817 / Impacted TSs and TRs: 28.545
- 2865: 6/3/17: 0%->30¦21/3/17: 29.827 added;¦5/6/17: 30%->60¦8/9/17: WID:CP-160822->CP-172058¦11/9/17: FCD:06/17->12/17 / Impacted TSs and TRs: 29.827
- 2866: 6/3/17: 0%->30¦21/3/17: 29.827 added;¦5/6/17: 30%->60¦8/9/17: WID:CP-160822->CP-172058¦11/9/17: FCD:06/17->12/17¦15/12/17: 60%->61¦15/12/17: 61%->100 / Impacted TSs and TRs: 29.827
- 2867: 15/12/17: 0%->100 / Impacted TSs and TRs: 29.827
- 2868: 7/6/18: 0%->100 / Impacted TSs and TRs: 24.605; 24.147
- 2869: 7/6/18: 0%->100 / Impacted TSs and TRs: 29.212; 29.213; 29.214
- 2870: 30/6/17: 26.238 added;¦11/9/17: 0%->10¦15/12/17: 10%->85¦15/12/17: FCD:12/17->06/18¦21/12/17: WID:SP-170576->SP-170824¦16/3/18: 85%->90¦7/6/18: 90%->100 / Impacted TSs and TRs: New TS; 26.238
- 2871: 15/12/17: 0%->80¦10/9/18: 80%->100 / Impacted TSs and TRs: 28.627; 28.628; 28.629; 28.658; 28.659
- 2872: 3/3/17: WID:SP-160779->SP-170031¦6/3/17: 0%->15¦7/6/17: 15%->60¦11/9/17: 60%->100 / Impacted TSs and TRs: 26.247; 26.233
- 2873: 15/12/17: 0%->50¦15/12/17: FCD:12/17->03/18¦21/12/17: WID:SP-170608->SP-170827¦16/3/18: 50%->60¦16/3/18: FCD:03/18->06/18¦7/6/18: 60%->100 / Impacted TSs and TRs: 26.247; 26.346; 26.347; TR26.946
- 2874: ASN.1-type of WID, hence later than St3, indpt of CUPS Rel-14¦16/3/18: 0%->5¦7/6/18: 5%->60¦10/9/18: 60%->100 / Impacted TSs and TRs: 32.426; 32.455; 28.658; 28.707; 28.708; 28.709
- 2875: 11/9/17: 0%->10¦15/12/17: 10%->80¦16/3/18: 80%->100 / Impacted TSs and TRs: 26.114

| ID | WBS | Task | Duration | Start | Finish | Complete | Remaining | Total slack | Constraint | Resources | Work | Actual work | Acronym | PCG approved | WI rapporteur name | Release | TSG approved | WI rapporteur e-mail | TSG stopped | Status Report |
| --- | --- | --- | --- | --- | --- | --- | --- | --- | --- | --- | --- | --- | --- | --- | --- | --- | --- | --- | --- | --- |
| 2876 | 1188 | **Enhanced Calling Name Service** | 390d? | 2016-09-15 A | 2018-03-14 A | 100% |  |  |  |  | 5424h | 5424h | eCNAM | 37 | Hala Mowafy, Ericsson | Rel-15 | 73 |  |  |  |
| 2877 | 1188.1 | Stage 1 of eCNAM | 66d? | 2016-09-15 A | 2016-12-15 A | 100% |  |  | finish no earlier than 2016-12-15 | S1 | 528h | 528h | eCNAM | 37 | Hala Mowafy, Ericsson | Rel-15 | 73 |  |  |  |
| 2878 | 1188.2 | **CT aspects of eCNAM** | 204d? | 2017-06-02 A | 2018-03-14 A | 100% |  |  |  | ct | 4896h | 4896h | eCNAM-CT | 39 | Mowafy, Hala. Ericsson | Rel-15 | 76 | hala.mowafy@ericsson.com |  |  |
| 2879 | 1188.2.1 | CT1 aspects of eCNAM | 204d? | 2017-06-02 A | 2018-03-14 A | 100% |  |  | finish no earlier than 2018-03-14 | C1 | 1632h | 1632h | eCNAM-CT | 39 | Mowafy, Hala. Ericsson | Rel-15 | 76 | hala.mowafy@ericsson.com |  |  |
| 2880 | 1188.2.2 | CT3 aspects of eCNAM | 204d? | 2017-06-02 A | 2018-03-14 A | 100% |  |  | finish no earlier than 2018-03-14 | C3 | 1632h | 1632h | eCNAM-CT | 39 | Mowafy, Hala. Ericsson | Rel-15 | 76 | hala.mowafy@ericsson.com |  |  |
| 2881 | 1189 | Enhancement of background data transfer | 38d? | 2017-01-16 A | 2017-03-08 A | 100% |  |  | finish no earlier than 2017-03-08 | S1 | 304h | 304h | eBT | 38 | Atsushi Minokuchi, NTT DOCOMO | Rel-15 | 75 | minokuchi at nttdocomo dot com |  |  |
| 2882 | 1190 | **Stage-3 SAE Protocol Development - Phase 6** | 272d? | 2017-06-02 A | 2018-06-18 A | 100% |  |  |  | C1 | 8704h | 8704h | SAES6 | 39 | Interdigital, Aghili, Behrouz | Rel-15 | 76 | Behrouz.aghili@interdigital.com |  |  |
| 2883 | 1190.1 | SAES6 CS Fallback in EPS | 272d? | 2017-06-02 A | 2018-06-18 A | 100% |  |  | start no earlier than 2017-06-02 | C1 | 2176h | 2176h | SAES6-CSFB | 39 | Interdigital, Aghili, Behrouz | Rel-15 | 76 | Behrouz.aghili@interdigital.com |  |  |
| 2884 | 1190.2 | SAES6 for support for non-3GPP accesses | 272d? | 2017-06-02 A | 2018-06-18 A | 100% |  |  | start no earlier than 2017-06-02 | C1 | 2176h | 2176h | SAES6-non3GPP | 39 | Interdigital, Aghili, Behrouz | Rel-15 | 76 | Behrouz.aghili@interdigital.com |  |  |
| 2885 | 1190.3 | SAE Protocol Development (Stage 3) - Phase 6 | 272d? | 2017-06-02 A | 2018-06-18 A | 100% |  |  | start no earlier than 2017-06-02 | C1 | 2176h | 2176h | SAES6 | 37 |  | Rel-15 | 72 |  |  |  |
| 2886 | 1191 | Security Assurance Specification for eNB network product class | 322d? | 2016-09-19 A | 2017-12-12 A | 100% |  |  | finish no earlier than 2017-12-12 | S3 | 2576h | 2576h | SCAS_eNB | 37 | Marcus Wong, Huawei Technologies | Rel-15 | 73 | mwong@huawei.com |  |  |
| 2887 | 1192 | Security Assurance Specification for PGW network product class | 389d? | 2016-06-17 A | 2017-12-12 A | 100% |  |  | finish no earlier than 2017-12-12 | S3 | 3112h | 3112h | SCAS_PGW | 37 | Peng Jin, China Mobile | Rel-15 | 72 | pengjin@chinamobile.com |  |  |
| 2888 | 1193 | HPLMN Radio Access Technology deployment Optimisation in Network Selection | 76d? | 2017-03-02 A | 2017-06-15 A | 100% |  |  | finish no earlier than 2017-06-15 | S1 | 608h | 608h | HORNS | 38 | Eddy Hall, Qualcomm Incorporated | Rel-15 | 75 | edhall@qti.qualcomm.com |  |  |
| 2889 | 1194 | **IMS Stage-3 IETF Protocol Alignment** | 755d? | 2017-06-02 A | 2020-04-23 | 99% | 0d? | 0d |  | ct | 21336h | 12142.6h | IMSProtoc9 | 39 | Dr. Belling, Thomas, Nokia | Rel-15 | 76 | Thomas.Belling@nokia.com |  |  |
| 2890 | 1194.1 | CT1 aspects of IMS Stage-3 IETF Protocol Alignment | 269d? | 2017-06-02 A | 2018-06-13 A | 100% |  |  | finish no earlier than 2018-06-13 | C1 | 2152h | 2152h | IMSProtoc9 | 39 | Dr. Belling, Thomas, Nokia | Rel-15 | 76 | Thomas.Belling@nokia.com |  |  |
| 2891 | 1194.2 | **(IETF) CT1 aspects of IMS Stage-3 IETF Protocol Alignment** | 755d? | 2017-06-02 A | 2020-04-23 | 99% | 0d? | 0d |  | C1-IETF | 10992h | 7120h | IMSProtoc9 | 39 | Dr. Belling, Thomas, Nokia | Rel-15 | 76 | Thomas.Belling@nokia.com |  |  |
| 2892 | 1194.2.1 | (IETF) Content-ID header field in SIP (draft-ietf-sipcore-content-id) | 271d? | 2017-06-02 A | 2018-06-15 A | 100% |  |  | finish no earlier than 2018-06-15 | C1-IETF | 2168h | 2168h | IMSProtoc9 | 40 | Christer Holmberg | Rel-15 | 78 | christer.holmberg@ericsson.com |  |  |
| 2893 | 1194.2.2 | (IETF) P-Visited-Network header updated (was: draft-jesske-update-p-visited-network ) | 271d? | 2017-06-02 A | 2018-06-15 A | 100% |  |  | finish no earlier than 2018-06-15 | C1-IETF | 2168h | 2168h | IMSProtoc9 | 40 | Michael KREIPL, Deutsche Telekom | Rel-15 | 78 | michael(dot)kreipl(at)telekom(dot)de |  |  |
| 2894 | 1194.2.3 | (IETF) Update to Private Header Field P-Visited-Network-ID in Session Initiation Protocol (SIP) Requests and Responses (draft-jesske-update-p-visited-network) | 77d | 2020-01-08 A | 2020-04-23 A | 100% |  |  | start no earlier than 2020-01-08 | C1-IETF | 616h | 616h | IMSProtoc8 | 44 | Michael KREIPL, Deutsche Telekom | Rel-15 | 87 | michael(dot)kreipl(at)telekom(dot)de |  |  |
| 2895 | 1194.3 | CT3 aspects of IMS Stage-3 IETF Protocol Alignment | 269d? | 2017-06-02 A | 2018-06-13 A | 100% |  |  | finish no earlier than 2018-06-13 | C3 | 2152h | 2152h | IMSProtoc9 | 39 | Dr. Belling, Thomas, Nokia | Rel-15 | 76 | Thomas.Belling@nokia.com |  |  |
| 2896 | 1195 | **Lawful Interception Rel-15** | 529d? | 2017-03-02 A | 2019-03-12 A | 100% |  |  |  |  | 7448h | 7448h | LI15 | 38 | Alex Leadbeater, BT | Rel-15 | 75 | alex.leadbeater@bt.com |  |  |
| 2897 | 1195.1 | Stopped - Study on R15 Lawful Interception Service | 402d? | 2017-03-02 A | 2018-09-14 A | 100% |  |  | finish no earlier than 2018-09-14 | S3LI | 3216h | 3216h | FS_15LIS | 38 | Gerry McQuaid, Vodafone | Rel-15 | 75 | Gerald.McQuaid@vodafone.com | 82 |  |
| 2898 | 1195.2 | Normative work on Lawful Interception Rel-15 | 529d? | 2017-03-02 A | 2019-03-12 A | 100% |  |  | finish no earlier than 2019-03-12 | S3LI | 4232h | 4232h | LI15 | 38 | Alex Leadbeater, BT | Rel-15 | 75 | alex.leadbeater@bt.com |  |  |
| 2899 | 1196 | **DL interference mitigation for UMTS** | 67d? | 2017-03-15 A | 2017-06-15 A | 100% |  |  |  | R2 | 1072h | 1072h | UTRA_DL_IM | 38 | Qualcomm | Rel-15 | 75 |  |  |  |
| 2900 | 1196.1 | Core part: DL interference mitigation for UMTS | 67d? | 2017-03-15 A | 2017-06-15 A | 100% |  |  | finish no earlier than 2017-06-15 | R2 | 536h | 536h | UTRA_DL_IM-Core | 38 | Qualcomm | Rel-14 | 75 |  |  | RP-171135 |
| 2901 | 1197 | Control and monitoring of Power, Energy and Environmental (PEE) parameters in Radio Access Networks (RAN) | 204d? | 2017-06-05 A | 2018-03-15 A | 100% |  |  | finish no earlier than 2018-03-15 | S5 | 1632h | 1632h | PEE_CMON | 39 | Jean-Michel CORNILY, ORANGE | Rel-15 | 76 |  |  |  |

Notes:
- 2876: 1/12/16: 0%->100 / Impacted TSs and TRs: 22.173
- 2877: 1/12/16: 0%->100¦30/6/17: 24.196 added; / Impacted TSs and TRs: 22.173; 24.196
- 2879: 14/9/17: 0%->40¦15/12/17: 40%->85¦20/3/18: 85%->100 / Impacted TSs and TRs: 24.259; 24.604; 24.606; 24.607; 24.608; 24.610; 24.611; 24.615; 24.616; 24.629; 24.642; 24.647; 24.654
- 2880: 7/6/18: 0%->100 / Impacted TSs and TRs: 29.165
- 2881: Impacted TSs and TRs: 22.101
- 2882: Impacted TSs and TRs: 23.122; 24.008; 24.167; 24.229; 24.301; 24.302; 24.303; 24.304; 24.305; 24.312; 29.018; 29.118; 24.368
- 2883: 14/9/17: 0%->20¦15/12/17: 20%->55¦16/3/18: 55%->80¦7/6/18: 80%->100 / Impacted TSs and TRs: 23.122; 24.008; 24.167; 24.229; 24.301; 24.302; 24.303; 24.304; 24.305; 24.312; 29.018; 29.118; 24.368
- 2884: 14/9/17: 0%->20¦15/12/17: 20%->55¦16/3/18: 55%->80¦7/6/18: 80%->100 / Impacted TSs and TRs: 23.122; 24.008; 24.167; 24.229; 24.301; 24.302; 24.303; 24.304; 24.305; 24.312; 29.018; 29.118; 24.368
- 2885: 14/9/17: 0%->20¦15/12/17: 20%->55¦16/3/18: 55%->80¦7/6/18: 80%->100
- 2886: 6/10/16: 33.216 added¦1/12/16: 0%->5¦6/3/17: 5%->25. Moved from Rel-14.¦7/6/17: FCD:06/17->12/17¦7/6/17: 25%->75¦11/9/17: 75%->100 / Impacted TSs and TRs: 33.117; 33.926; 33.216
- 2887: 28/7/16: 33.250 added¦19/9/16: 0%->10¦6/10/16: 33.216 added¦1/12/16: 10%->40. 06/03/17: moved from Rel-14.¦6/3/17: 40%->80¦7/6/17: FCD:06/17->12/17¦7/6/17: 80%->95¦11/9/17: 95%->100 / Impacted TSs and TRs: 33.250; 33.216
- 2888: 7/6/17: 75%->100
- 2890: 14/9/17: 0%->40¦15/12/17: 40%->60¦16/3/18: 60%->80¦7/6/18: 80%->100 / Impacted TSs and TRs: 23.218; 24.229; 24.930
- 2892: 22/3/18: 0%->100; 9/4/21: RFC 8262 added; / Impacted TSs and TRs: RFC 8262
- 2893: 27/6/18: 0%->100
- 2895: 15/12/17: 0%->40¦7/6/18: 40%->85¦10/9/18: 85%->100 / Impacted TSs and TRs: 29.163; 29.165; 29.949
- 2896: 21/12/17: WID:SP-170039->SP-170839¦16/3/18: 10%->20
- 2897: 12/7/17: 0%->5¦11/9/17: 5%->10¦16/3/18: 24%->35¦7/6/18: 35%->70¦7/6/18: FCD:06/18->09/18¦10/9/18: 70%->85. 17/01/19: deleted as per Alex's e-mail 13 Nov. Was at 85%
- 2898: 12/7/17: 0%->5¦15/12/17: 5%->10¦10/9/18: 17%->40¦7/12/18: FCD:12/18->03/19¦7/12/18: 40%->75¦20/3/19: 75%->80; 31/5/19: 80%->100
- 2899: no Perf. part
- 2900: no Perf. part19/6/17: Compl:0%->100%
- 2901: 30/6/17: 28.306 added;¦30/6/17: 28.305 added;¦30/6/17: 28.304 added;¦11/9/17: 0%->20¦15/12/17: 20%->80¦16/3/18: 80%->100 / Impacted TSs and TRs: New TSs; 52.402; 32.405; 32.425; 32.101; 32.103; 28.306; 28.305; 28.304

| ID | WBS | Task | Type | Duration | Start | Finish | Complete | Remaining | Total slack | Constraint | Resources | Work | Actual work | Acronym | PCG approved | WI rapporteur name | Release | TSG approved | Impacted TSs and TRs | WI rapporteur e-mail | Status Report |
| --- | --- | --- | --- | --- | --- | --- | --- | --- | --- | --- | --- | --- | --- | --- | --- | --- | --- | --- | --- | --- | --- |
| 2902 | 1198 | **Simplified HS-SCCH for UMTS** |  | 198d? | 2017-03-15 A | 2017-12-15 A | 100% |  |  |  | R6 | 3176h | 3176h | UTRA_simple_HSSCCH | 39 | Ericsson | Rel-15 | 76 |  |  |  |
| 2903 | 1198.1 | Study on a simplified HS-SCCH for UMTS |  | 67d? | 2017-03-15 A | 2017-06-15 A | 100% |  |  | start no earlier than 2017-03-15 | R1 | 536h | 536h | FS_UTRA_simple_HSSCCH | 38 | gerardo.agni.medina.acosta@ericsson.com | Rel-15 | 75 | 25.709 | gerardo.agni.medina.acosta@ericsson.com |  |
| 2904 | 1198.2 | Core part: Simplified HS-SCCH for UMTS |  | 132d? | 2017-06-15 A | 2017-12-15 A | 100% |  |  | finish no earlier than 2017-12-15 | R6 | 1056h | 1056h | UTRA_simple_HSSCCH-Core | 39 | Ericsson | Rel-15 | 76 |  |  | RP-172306 |
| 2905 | 1199 | Charging for enhancement to Flexible Mobile Service Steering (eFMSS) |  | 139d? | 2017-06-05 A | 2017-12-14 A | 100% |  |  | finish no earlier than 2017-12-14 | S5 | 1112h | 1112h | eFMSS_CH | 39 | Long,Biao, China Telecom | Rel-15 | 76 | 32.251; 32.298; 32.299 | longb.gd@chinatelecom.cn. |  |
| 2906 | 1200 | Receive acoustic output test in the presence of background noise |  | 131d? | 2017-12-15 A | 2018-06-15 A | 100% |  |  | finish no earlier than 2018-06-15 | S4 | 1048h | 1048h | RAOT | 40 | ISBERG, Peter, Sony Mobile Communications | Rel-15 | 78 | 26.131; 26.132 | peter.isberg [at] sony.com |  |
| 2907 | 1201 | Speech quality in the presence of ambient noise for super-wideband and fullband modes |  | 196d? | 2017-12-15 A | 2018-09-14 A | 100% |  |  | finish no earlier than 2018-09-14 | S4 | 1568h | 1568h | SPAN | 40 | Reimes, Jan – HEAD acoustics GmbH | Rel-15 | 78 | 26.131 | jan.reimes@head-acoustics.de |  |
| 2908 | 1202 | **REST Solution Sets** |  | 781d? | 2016-09-19 A | 2019-09-16 | 27% | 566.6d? | 1690d |  |  | 15112h | 4148.8h | REST_SS | 41 |  | Rel-15 | 78 |  |  |  |
| 2909 | 1202.1 | Study on a RESTful HTTP-based Solution Set |  | 322d? | 2016-09-19 A | 2017-12-12 A | 100% |  |  | finish no earlier than 2017-12-12 | S5 | 2576h | 2576h | FS_OAM_RESTFUL | 37 | Nokia: Pollakowski, Olaf | Rel-15 | 73 | 32.866 | olaf.pollakowski@nokia.com |  |
| 2910 | 1202.2 | REST Solution Sets (normative work) |  | 196d? | 2017-12-15 A | 2018-09-14 A | 100% |  |  | finish no earlier than 2018-09-14 | S5 | 1568h | 1568h | REST_SS | 40 | Pollakowski, Olaf, Nokia | Rel-15 | 78 | 32.101 | olaf.pollakowski@nokia.com |  |
| 2911 | 1202.3 | (IETF) JSON Schema: A Media Type for Describing JSON Documents (draft-handrews-json-schema) |  | 457d? | 2017-12-15 A | 2019-09-16 |  | 456.8d? | 1690d | finish no earlier than 2019-09-16 | S5-IETF | 3656h | 1.6h | REST_SS | 41 | Pollakowski, Olaf, Nokia | Rel-15 | 80 |  | olaf.pollakowski@nokia.com |  |
| 2912 | 1202.4 | (IETF) JSON Schema Validation: A Vocabulary for Structural Validation of JSON (draft-handrews-json-schema-validation) |  | 457d? | 2017-12-15 A | 2019-09-16 |  | 456.8d? | 1690d | finish no earlier than 2019-09-16 | S5-IETF | 3656h | 1.6h | REST_SS | 41 | Pollakowski, Olaf, Nokia | Rel-15 | 80 |  | olaf.pollakowski@nokia.com |  |
| 2913 | 1202.5 | (IETF) JSON Hyper-Schema: A Vocabulary for Hypermedia Annotation of JSON (draft-handrews-json-schema-hyperschema) |  | 457d? | 2017-12-15 A | 2019-09-16 |  | 456.8d? | 1690d | finish no earlier than 2019-09-16 | S5-IETF | 3656h | 1.6h | REST_SS | 41 | Pollakowski, Olaf, Nokia | Rel-15 | 80 |  | olaf.pollakowski@nokia.com |  |
| 2914 | 1203 | **Enhancements to Call spoofing functionality** |  | 256d? | 2018-03-15 A | 2019-03-07 | 99% | 0d? | 0d |  | C1 | 3648h | 1688h | eSPECTRE | 41 | Axell, Jörgen, Ericsson | Rel-15 | 79 |  | Jorgen.Axell@ericsson.com |  |
| 2915 | 1203.1 | CT1 aspects of eSPECTRE |  | 66d? | 2018-03-15 A | 2018-06-14 A | 100% |  |  | start no earlier than 2018-03-15 | C1 | 528h | 528h | eSPECTRE | 40 | Axell, Jörgen, Ericsson | Rel-15 | 79 | 24.229 | Jorgen.Axell@ericsson.com |  |
| 2916 | 1203.2 | (IETF) PASSporT SHAKEN Extension (draft-ietf-stir-passport-shaken)--> RFC 8588 |  | 67d? | 2018-06-14 A | 2018-09-14 A | 100% |  |  | start no earlier than 2018-06-14 | C1-IETF | 536h | 536h | eSPECTRE | 41 | Axell, Jörgen, Ericsson | Rel-15 | 80 |  |  |  |
| 2917 | 1203.3 | (IETF) PASSporT Extension for Diverted Calls (draft-ietf-stir-passport-divert) |  | 1d | 2019-03-07 A | 2019-03-07 A | 100% |  |  |  | C1-IETF | 8h | 8h | eSPECTRE | 44 |  | Rel-15 | 87 | RFC 8946 |  |  |
| 2918 | 1203.4 | CT3 aspects of eSPECTRE |  | 66d? | 2018-03-15 A | 2018-06-14 A | 100% |  |  | start no earlier than 2018-03-15 | C3 | 528h | 528h | eSPECTRE | 40 | Axell, Jörgen, Ericsson | Rel-15 | 79 | 29.163; 29.165 | Jorgen.Axell@ericsson.com |  |
| 2919 | 1204 | **(Small) Technical Enhancements and Improvements for Rel-15** |  | 326d? | 2017-03-17 A | 2018-06-15 A | 100% |  |  |  |  | 2608h | 2608h | TEI15 | 35 |  | Rel-15 | 68 |  |  |  |
| 2920 | 1204.1 | (IETF) The Transport Layer Security (TLS) Protocol Version 1.3 (draft-ietf-tls-tls13) |  | 326d? | 2017-03-17 A | 2018-06-15 A | 100% |  |  | finish no earlier than 2018-06-15 | S3-IETF | 2608h | 2608h | TEI15 | 41 |  | Rel-15 | 80 | RFC 8446 |  |  |
| 2921 | 1205 | (Small) Test Technical Enhancements and Improvements for Rel-15 |  | 196d? | 2017-03-17 A | 2017-12-15 A | 100% |  |  | finish no earlier than 2017-12-15 |  |  |  | TEI15_Test | 38 |  | Rel-15 | 75 |  |  |  |
| 2922 | 1206 | Release 15 Features on LTE improvements | milestone | 0d? | 2000-01-01 A | 2000-01-01 A | 100% |  |  |  |  |  |  |  |  |  | Rel-15 |  |  |  |  |
| 2923 | 1207 | **UL data compression in LTE** |  | 5029d? | 2000-01-03 A | 2019-03-15 | 99% | 48.34d? | 1821d |  | R2 | 80992h | 78130.7h | LTE_UDC | 39 | CATT | Rel-15 | 77 |  |  |  |
| 2924 | 1207.1 | Core part: UL data compression in LTE |  | 4899d? | 2000-01-03 A | 2018-09-14 | 99% | 48.99d? | 1951d | finish no earlier than 2018-09-15 | R2 | 39192h | 38800.1h | LTE_UDC-Core | 39 | CATT | Rel-15 | 77 |  |  | RP-180912 |
| 2925 | 1207.2 | UE Conformance Test Aspects - UL Data Compression in LTE |  | 196d? | 2018-06-15 A | 2019-03-15 A | 100% |  |  | finish no earlier than 2019-03-15 | R5 | 1568h | 1568h | LTE_UDC-UEConTest | 41 | CATT | Rel-15 | 80 |  |  |  |

Notes:
- 2903: 19/6/17: Compl:0%->100%¦30/6/17: 25.709 added;
- 2904: 11/9/17: 0%->85¦15/12/17: 85%->100¦8/1/18: WID: RP-171443->RP-172720¦
- 2905: 11/9/17: 0%->70¦15/12/17: 70%->100
- 2906: 16/3/18: 0%->80¦16/3/18: FCD:03/18->06/18¦7/6/18: 80%->100
- 2907: 16/3/18: 0%->50¦7/6/18: 50%->80¦7/6/18: FCD:06/18->09/18¦10/9/18: 80%->100
- 2909: 6/10/16: 32.866 added¦1/12/16: 0%->5¦7/6/17: 5%->45¦7/6/17: FCD:06/17->12/17¦11/9/17: 45%->80¦15/12/17: 80%->100
- 2910: 16/3/18: 0%->20¦7/6/18: 20%->70¦7/6/18: FCD:06/18->09/18¦10/9/18: 70%->100
- 2915: 16/3/18: 0%->5; 7/6/18: 5%->50; 10/9/18: 50%->100
- 2916: 23/4/20: 25%->100
- 2917: 9/4/21: RFC 8946 added;
- 2918: 10/9/18: 0%->100
- 2920: 26/6/19: 25%->100; 9/4/21: RFC 8446 added;
- 2921: Created upon demand of RAN5
- 2922: -
- 2924: ¦8/1/18: Compl:0%->70%¦8/1/18: CD:Mon 03/01/00->Thu 15/03/18¦27/3/18: Compl:70%->99%27/3/1 ¦27/6/18: CD:Fri 15/06/18->Sat 15/09/18;
- 2925: tested: REL-15 WI LTE_UDC-Core¦26/3/19: WID:RP-180918->RP-190311¦26/3/19: 0%->100

| ID | WBS | Task | Duration | Start | Finish | Complete | Remaining | Total slack | Constraint | Resources | Work | Actual work | Acronym | PCG approved | WI rapporteur name | Release | TSG approved | Impacted TSs and TRs | TSG stopped | WI rapporteur e-mail | Status Report |
| --- | --- | --- | --- | --- | --- | --- | --- | --- | --- | --- | --- | --- | --- | --- | --- | --- | --- | --- | --- | --- | --- |
| 2926 | 1208 | **LTE Advanced inter-band CA (4DL/4UL) of Band 41C and Band 42C** | 130d? | 2017-09-15 A | 2018-03-15 A | 100% |  |  |  | R4 | 3120h | 3120h | LTE_CA_4DL4UL_B41_B41_B42_B42 | 39 | KDDI | Rel-15 | 77 |  |  |  |  |
| 2927 | 1208.1 | Core part:LTE Advanced inter-band CA (4DL/4UL) of Band 41C and Band 42C | 130d? | 2017-09-15 A | 2018-03-15 A | 100% |  |  | finish no earlier than 2018-06-15 | R4 | 1040h | 1040h | LTE_CA_4DL4UL_B41_B41_B42_B42-Core | 39 | KDDI | Rel-15 | 77 | 36.715-04 |  |  |  |
| 2928 | 1208.2 | Perf. part:LTE Advanced inter-band CA (4DL/4UL) of Band 41C and Band 42C | 130d? | 2017-09-15 A | 2018-03-15 A | 100% |  |  | finish no earlier than 2018-06-15 | R4 | 1040h | 1040h | LTE_CA_4DL4UL_B41_B41_B42_B42-Perf | 39 | KDDI | Rel-15 | 77 |  |  |  |  |
| 2929 | 1209 | **Additional LTE bands for UE category M1 and/or NB1 in Rel-15** | 196d? | 2017-09-15 A | 2018-06-15 A | 100% |  |  |  | R4 | 5752h | 5752h | LTE_bands_R15_M1_NB1 | 39 | Ericsson | Rel-15 | 77 |  |  |  |  |
| 2930 | 1209.1 | Core part: Additional LTE bands for UE category M1 and/or NB1 in Rel-15 | 196d? | 2017-09-15 A | 2018-06-15 A | 100% |  |  | finish no earlier than 2018-06-15 | R4 | 1568h | 1568h | LTE_bands_R15_M1_NB1-Core | 39 | Ericsson | Rel-15 | 77 |  |  |  |  |
| 2931 | 1209.2 | Perf. part: Additional LTE bands for UE category M1 and/or NB1 in Rel-15 | 196d? | 2017-09-15 A | 2018-06-15 A | 100% |  |  | finish no earlier than 2018-06-15 | R4 | 1568h | 1568h | LTE_bands_R15_M1_NB1-Perf | 39 | Ericsson | Rel-15 | 77 |  |  |  |  |
| 2932 | 1209.3 | UE Conformance Test aspects - LTE bands with UE category M1 and/or NB1 in Rel-15 | 131d? | 2017-12-15 A | 2018-06-15 A | 100% |  |  | finish no earlier than 2018-06-15 | R5 | 1048h | 1048h | LTE_bands_R15_M1_NB1-UEConTest | 40 | Ericsson | Rel-15 | 78 |  |  |  |  |
| 2933 | 1210 | **Additional LTE bands for UE category M2 and/or NB2 in Rel-15** | 326d? | 2017-09-15 A | 2018-12-14 A | 100% |  |  |  | R4 | 6264h | 6264h | LTE_bands_R15_M2_NB2 | 39 | Ericsson | Rel-15 | 77 |  |  |  |  |
| 2934 | 1210.1 | Core part: Additional LTE bands for UE category M2 and/or NB2 in Rel-15 | 196d? | 2017-09-15 A | 2018-06-15 A | 100% |  |  | finish no earlier than 2018-06-15 | R4 | 1568h | 1568h | LTE_bands_R15_M2_NB2-Core | 39 | Ericsson | Rel-15 | 77 |  |  |  |  |
| 2935 | 1210.2 | UE Conformance Test aspects - LTE bands with UE category M2 and/or NB2 in Rel-15 | 261d? | 2017-12-15 A | 2018-12-14 A | 100% |  |  | finish no earlier than 2018-12-15 | R5 | 2088h | 2088h | LTE_bands_R15_M2_NB2-UEConTest | 40 | Ericsson | Rel-15 | 78 |  |  |  |  |
| 2936 | 1211 | **Extended-Band12 new E-UTRA Band** | 446d? | 2017-09-15 A | 2019-05-31 A | 100% |  |  |  | R4 | 6176h | 6176h | Ext_B12_LTE | 39 | Ericsson | Rel-15 | 77 |  |  |  |  |
| 2937 | 1211.1 | Core part: Extended-Band12 new E-UTRA Band | 130d? | 2017-09-15 A | 2018-03-15 A | 100% |  |  | finish no earlier than 2018-03-15 | R4 | 1040h | 1040h | Ext_B12_LTE-Core | 39 | Ericsson | Rel-15 | 77 | 37.761 |  |  |  |
| 2938 | 1211.2 | Perf. part: Extended-Band12 new E-UTRA Band | 130d? | 2017-09-15 A | 2018-03-15 A | 100% |  |  | finish no earlier than 2018-03-15 | R4 | 1040h | 1040h | Ext_B12_LTE-Perf | 39 | Ericsson | Rel-15 | 77 |  |  |  |  |
| 2939 | 1211.3 | UE Conformance Test Aspects - Extended-Band12 new E-UTRA Band (Band 85) | 66d | 2019-03-01 A | 2019-05-31 A | 100% |  |  | finish no earlier than 2019-06-01 | R5 | 528h | 528h | Ext_B12_LTE-UEConTest | 42 | Ericsson | Rel-15 | 83 |  |  |  |  |
| 2940 | 1212 | **Stopped - Signalling reduction to enable light connection for LTE** | 524d? | 2016-03-15 A | 2018-03-15 A | 100% |  |  |  |  | 7120h | 7120h | LTE_LIGHT_CON | 36 | Huawei | Rel-15 | 71 |  | 80 |  |  |
| 2941 | 1212.1 | Stopped - Core part: Signalling reduction to enable light connection for LTE | 524d? | 2016-03-15 A | 2018-03-15 A | 100% |  |  | finish no earlier than 2018-03-15 | R2 | 4192h | 4192h | LTE_LIGHT_CON-Core | 36 | Huawei | Rel-15 | 71 |  | 80 |  |  |
| 2942 | 1212.2 | Stopped - Study on Stage 2 of LTE_LIGHT_CON | 70d? | 2017-03-10 A | 2017-06-15 A | 100% |  |  | finish no earlier than 2017-06-15 | S2 | 560h | 560h | FS_LTE_LIGHT_CON | 38 | Sašo Stojanovski , intel | Rel-15 | 75 | 23.723 | 80 | saso.stojanovski@intel.com |  |
| 2943 | 1212.3 | **Stopped - Stage 3 of LTE_LIGHT_CON** | 74d? | 2016-12-01 A | 2017-03-14 A | 100% |  |  |  | ct | 2368h | 2368h | LTE_LIGHT_CON-CT | 38 | Herrero Veron, Christian (Huawei) | Rel-15 | 74 |  | 80 | Christian.Herrero at huawei.com |  |
| 2944 | 1212.3.1 | Stopped - CT1 aspects of LTE_LIGHT_CON | 74d? | 2016-12-01 A | 2017-03-14 A | 100% |  |  | finish no earlier than 2017-03-14 | C1 | 592h | 592h | LTE_LIGHT_CON-CT | 38 | Herrero Veron, Christian (Huawei) | Rel-15 | 74 | 24.008; 24.301; 29.118; 24.368; 27.007 | 80 | Christian.Herrero at huawei.com |  |
| 2945 | 1212.3.2 | Stopped - CT4 aspects of LTE_LIGHT_CON | 74d? | 2016-12-01 A | 2017-03-14 A | 100% |  |  | finish no earlier than 2017-03-14 | C4 | 592h | 592h | LTE_LIGHT_CON-CT | 38 | Herrero Veron, Christian (Huawei) | Rel-15 | 74 | 29.274; 29.272 | 80 | Christian.Herrero at huawei.com |  |
| 2946 | 1212.3.3 | Stopped - CT6 aspects of LTE_LIGHT_CON | 74d? | 2016-12-01 A | 2017-03-14 A | 100% |  |  | finish no earlier than 2017-03-14 | C6 | 592h | 592h | LTE_LIGHT_CON-CT | 38 | Herrero Veron, Christian (Huawei) | Rel-15 | 74 | 31.102 | 80 | Christian.Herrero at huawei.com |  |
| 2947 | 1213 | **Enhancements of Base Station (BS) RF and EMC requirements for Active Antenna System (AAS)** | 655d? | 2016-03-15 A | 2018-09-14 | 71% | 192.39d? | 1951d |  |  | 8920h | 6300h | AASenh_BS_LTE_UTRA | 36 | Huawei | Rel-15 | 71 | 37.843 |  |  |  |
| 2948 | 1213.1 | Core part: Enhancements of Base Station (BS) RF and EMC requirements for Active Antenna System (AAS) | 460d? | 2016-03-15 A | 2017-12-15 A | 100% |  |  | finish no earlier than 2017-12-15 | R4 | 3680h | 3680h | AASenh_BS_LTE_UTRA-Core | 36 | Huawei | Rel-15 | 71 |  |  |  | RP-172345 |
| 2949 | 1213.2 | Perf. part: Enhancements of Base Station (BS) RF and EMC requirements for Active Antenna System (AAS) | 655d? | 2016-03-15 A | 2018-09-14 | 50% | 327.5d? | 1951d | finish no earlier than 2018-09-15 | R4 | 5240h | 2620h | AASenh_BS_LTE_UTRA-Perf | 36 | Huawei | Rel-15 | 71 |  |  |  |  |

Notes:
- 2927: 15/12/17: 36.715-04 added;¦8/1/18: Compl:0%->80%27/3/18: Compl:80%->100%;
- 2928: ¦27/3/18: Compl:0%->100%;
- 2930: ¦8/1/18: Compl:0%->99%27/3/18: WID: RP-172077->RP-180262¦27/6/18: Compl:99%->100%
- 2931: ¦27/3/18: Compl:0%->99% ¦27/6/18: Compl:99%->100%
- 2932: tested: REL-15 WI LTE_bands_R15_M1_NB1-Core27/3/ ;
- 2934: ¦8/1/18: Compl:0%->99%¦27/3/18: WID: RP-172078->RP-180261¦27/6/18: Compl:99%->100%
- 2935: tested: REL-15 WI LTE_bands_R15_M2_NB2-Core¦27/ ;; 8/10/19: 20%->100
- 2937: 15/12/17: 37.761 added;¦8/1/18: Compl:0%->25%¦27/3/18: Compl:25%->100%;
- 2938: ¦8/1/18: WID: RP-172111->RP-17262527/3/18: Compl:0%->100%
- 2939: 26/6/19: WID:RP-190510->RP-190937; 26/6/19: 0%->100
- 2940: no Perf. part¦14/9/17: WID:RP-160540->RP-160937¦14/9/17: WID:RP-160937->RP-171459
- 2941: no Perf. part¦1/7/16: Compl:0%->10%¦1/7/16: CD:Thu 15/12/16->Wed 15/03/17¦1/7/16: WID: RP-160540->RP-16093726/9/16: Compl:10%->30%¦20/12/16: Compl:30%->75%¦20/12/16: Stat Rep: --> 21/3/17: Compl:75%->79% 21/3/17: CD:W ¦27/6
- 2942: 21/3/17: 23.723 added;¦7/6/17: 0%->55. Stopped at 55%, set at 100% artificially
- 2944: 6/3/17: 0%->25¦11/9/17: 25%->0
- 2946: 7/3/17: 0%->100
- 2947: follow-up WI of REL-13 WI AAS_BS_LTE_UTRA¦14/9/17: WID:RP-160548->RP-161668
- 2948: follow-up WI of REL-13 WI AAS_BS_LTE_UTRA1/7/16: Compl:0%->5%1/7/16: CD:Fri 15/09/17->Wed 15/03/1726/9/16: Compl:5%->10% 20/12/16: Compl:10%->20%21/3/17: Compl:20%->40% ;
- 2949: 1/7/16: WID: RP-160548->RP-1609401/7/16: Release: Rel-15->Rel-14¦26/9/16: WID: RP-160940->RP-161668 20/12/16: Stat Rep: -->¦21/3/17: Compl:0%->10%;

| ID | WBS | Task | Type | Duration | Start | Finish | Complete | Remaining | Total slack | Constraint | Resources | Work | Actual work | Acronym | PCG approved | WI rapporteur name | Release | TSG approved | Status Report | Impacted TSs and TRs |
| --- | --- | --- | --- | --- | --- | --- | --- | --- | --- | --- | --- | --- | --- | --- | --- | --- | --- | --- | --- | --- |
| 2950 | 1214 | **Shortened TTI and processing time for LTE** |  | 1174d? | 2016-06-15 A | 2020-12-12 | 99% | 4.22d? | 1366d |  |  | 13072h | 13024.9h | LTE_sTTIandPT | 37 | Ericsson | Rel-15 | 72 |  |  |
| 2951 | 1214.1 | Core part: Shortened TTI and processing time for LTE |  | 589d? | 2016-06-15 A | 2018-09-14 | 99% | 5.89d? | 1951d | finish no earlier than 2018-09-15 | R1 | 4712h | 4664.88h | LTE_sTTIandPT-Core | 37 | Ericsson | Rel-15 | 72 | RP-181008 |  |
| 2952 | 1214.2 | Perf. part: Shortened TTI and processing time for LTE |  | 523d? | 2016-09-14 A | 2018-09-14 A | 100% |  |  | finish no earlier than 2018-09-15 | R4 | 4184h | 4184h | LTE_sTTIandPT-Perf | 37 | Ericsson | Rel-15 | 72 |  |  |
| 2953 | 1214.3 | UE Conformance Test Aspects - Shortened TTI and processing time for LTE | manual | 522d | 2018-12-15 A | 2020-12-12 A | 100% |  |  |  | R5 | 4176h | 4176h | LTE_sTTIandPT-UEConTest | 42 | Huawei | Rel-15 | 82 |  |  |
| 2954 | 1215 | **450MHz E-UTRA FDD Band for LTE PPDR and PMR/PAMR in Europe** |  | 326d? | 2016-12-15 A | 2018-03-15 A | 100% |  |  |  |  | 4192h | 4192h | LTE450_Europe_PPDR | 38 | Airbus | Rel-15 | 74 |  | 36.748 |
| 2955 | 1215.1 | Core part: 450MHz E-UTRA FDD Band for LTE PPDR and PMR/PAMR in Europe |  | 197d? | 2016-12-15 A | 2017-09-15 A | 100% |  |  | finish no earlier than 2017-09-15 | R4 | 1576h | 1576h | LTE450_Europe_PPDR-Core | 38 | Airbus | Rel-15 | 74 |  |  |
| 2956 | 1215.2 | Perf. part: 450MHz E-UTRA FDD Band for LTE PPDR and PMR/PAMR in Europe |  | 197d? | 2016-12-15 A | 2017-09-15 A | 100% |  |  | finish no earlier than 2017-09-15 | R4 | 1576h | 1576h | LTE450_Europe_PPDR-Perf | 38 | Airbus | Rel-15 | 74 |  |  |
| 2957 | 1215.3 | UE Conformance Test Aspects - 450MHz E-UTRA FDD Band for LTE PPDR and PMR/PAMR in Europe (Band 72) |  | 130d? | 2017-09-15 A | 2018-03-15 A | 100% |  |  | finish no earlier than 2018-03-15 | R5 | 1040h | 1040h | LTE450_Europe_PPDR-UEConTest | 39 | Airbus | Rel-15 | 77 |  |  |
| 2958 | 1216 | **E-UTRA 700MHz in Europe for Broadband-PPDR (Public Protection and Disaster Relief)** |  | 326d? | 2016-12-15 A | 2018-03-15 | 83% | 54.06d? | 2082d |  |  | 3136h | 2616h | LTE700_Europe_PPDR | 38 | Airbus | Rel-15 | 74 |  |  |
| 2959 | 1216.1 | Core part: E-UTRA 700MHz in Europe for Broadband-PPDR |  | 197d? | 2016-12-15 A | 2017-09-15 A | 100% |  |  | finish no earlier than 2017-09-15 | R4 | 1576h | 1576h | LTE700_Europe_PPDR-Core | 38 | Airbus | Rel-15 | 74 |  |  |
| 2960 | 1216.2 | Perf. part: E-UTRA 700MHz in Europe for Broadband-PPDR |  | 65d? | 2016-12-15 | 2017-03-15 |  |  | 2343d | finish no earlier than 2017-03-15 | R4 | 520h |  | LTE700_Europe_PPDR-Perf | 38 | Airbus | Rel-15 | 74 |  |  |
| 2961 | 1216.3 | UE Conformance Test Aspects - E-UTRA 700MHz in Europe for Broadband-PPDR |  | 130d? | 2017-09-15 A | 2018-03-15 A | 100% |  |  | finish no earlier than 2018-03-15 | R5 | 1040h | 1040h | LTE700_Europe_PPDR-UEConTest | 39 | Airbus | Rel-15 | 77 |  |  |
| 2962 | 1217 | **FDD operating band in the L-band for LTE** |  | 457d? | 2016-12-15 A | 2018-09-14 A | 100% |  |  |  |  | 4720h | 4720h | LTE_FDD_L_Band | 38 | NTT DOCOMO | Rel-15 | 74 |  | 36.751 |
| 2963 | 1217.1 | Core part: FDD operating band in the L-band for LTE |  | 197d? | 2016-12-15 A | 2017-09-15 A | 100% |  |  | finish no earlier than 2017-09-15 | R4 | 1576h | 1576h | LTE_FDD_L_Band-Core | 38 | NTT DOCOMO | Rel-15 | 74 |  |  |
| 2964 | 1217.2 | Perf. part: FDD operating band in the L-band for LTE |  | 197d? | 2016-12-15 A | 2017-09-15 A | 100% |  |  | finish no earlier than 2017-09-15 | R4 | 1576h | 1576h | LTE_FDD_L_Band-Perf | 38 | NTT DOCOMO | Rel-15 | 74 |  |  |
| 2965 | 1217.3 | UE Conformance Test Aspects - FDD operating band in the L-band for LTE |  | 196d? | 2017-12-15 A | 2018-09-14 A | 100% |  |  | finish no earlier than 2018-09-15 | R5 | 1568h | 1568h | LTE_FDD_L_band-UEConTest | 40 | NTT DOCOMO | Rel-15 | 78 |  |  |
| 2966 | 1218 | **LTE Extended 1.5 GHz SDL band (1427 – 1518 MHz) and LTE CA (2DL/1UL) with Band 20** |  | 197d? | 2016-12-15 A | 2017-09-15 A | 100% |  |  |  |  | 2624h | 2624h | LTE_SDL_1500ext | 38 | Qualcomm | Rel-15 | 74 |  | 36.934; 36.753 |
| 2967 | 1218.1 | Core part: LTE Extended 1.5 GHz SDL band (1427 – 1518 MHz) and LTE CA (2DL/1UL) with Band 20 |  | 197d? | 2016-12-15 A | 2017-09-15 A | 100% |  |  | finish no earlier than 2017-09-15 | R4 | 1576h | 1576h | LTE_SDL_1500ext-Core | 38 | Qualcomm | Rel-15 | 74 |  |  |
| 2968 | 1218.2 | Perf. part: LTE Extended 1.5 GHz SDL band (1427 – 1518 MHz) and LTE CA (2DL/1UL) with Band 20 |  | 131d? | 2017-03-17 A | 2017-09-15 A | 100% |  |  | finish no earlier than 2017-09-15 | R4 | 1048h | 1048h | LTE_SDL_1500ext-Perf | 38 | Qualcomm | Rel-15 | 74 |  |  |
| 2969 | 1219 | **Add UE Power Class 2 to band 41 intra-band contiguous LTE CA** |  | 522d? | 2016-12-15 A | 2018-12-14 A | 100% |  |  |  |  | 4184h | 4184h | LTE_CA_C_B41_PC2 | 38 | Sprint | Rel-15 | 74 |  |  |
| 2970 | 1219.1 | Core part: Add UE Power Class 2 to band 41 intra-band contiguous LTE CA |  | 262d? | 2016-12-15 A | 2017-12-15 A | 100% |  |  | finish no earlier than 2017-12-15 | R4 | 2096h | 2096h | LTE_CA_C_B41_PC2-Core | 38 | Sprint | Rel-15 | 74 |  |  |
| 2971 | 1219.2 | UE Conformance Test Aspects - Add UE Power Class 2 to band 41 intra-band contiguous LTE CA |  | 261d? | 2017-12-15 A | 2018-12-14 A | 100% |  |  | finish no earlier than 2018-12-15 | R5 | 2088h | 2088h | LTE_CA_C_B41_PC2-UEConTest | 40 | Sprint | Rel-15 | 78 |  |  |
| 2972 | 1220 | **Addition of Power Class 1 UE to bands B3/B20/B28 for LTE** |  | 262d? | 2016-09-15 A | 2017-09-15 A | 100% |  |  |  |  | 2096h | 2096h | LTE_HPUE_B3_B20_B28 | 37 | Motorola Solutions | Rel-15 | 73 |  |  |
| 2973 | 1220.1 | Core part: Addition of Power Class 1 UE to bands B3/B20/B28 for LTE |  | 262d? | 2016-09-15 A | 2017-09-15 A | 100% |  |  | finish no earlier than 2017-09-15 | R4 | 2096h | 2096h | LTE_HPUE_B3_B20_B28-Core | 37 | Motorola Solutions | Rel-15 | 73 |  |  |

Notes:
- 2951: 26/9/16: Compl:0%->5%¦20/12/16: Compl:5%->10%21/3/17: Compl:10%->30%19/6/17: Compl:30%->65%19/6/17: CD: 19/9/17: Compl:65%->75%¦8/1/18: Compl:75%->99%¦8/1/18: CD:Fri 15/12/17->F ¦27/6/18: CD:Fri 15/06/1
- 2952: ¦26/9/16: WID: RP-161299->RP-161922¦20/12/16: WID: RP-161922->RP-16201421/3/17: WID: RP-162014->RP-170113¦19/6/17: CD:Thu 15/03/18->Fri 15/06/1827/3/18: Compl:0%->33%¦27/6/18: Compl:33%->60%¦26/3/19: 60%->100
- 2953: tested: REL-15 WI LTE_sTTIandPT-Core; 26/6/19: WID:RP-182429->RP-191003; 8/10/20: 0%->90; 8/10/20: 0%->90; 8/10/20: FCD:20/06/2019->12/20; 7/4/21: 0%->100; 8/4/21: 100%->100
- 2954: 21/3/17: 36.748 added;
- 2955: 21/3/17: Compl:0%->10%¦19/6/17: Compl:10%->75%¦19/9/17: Compl:75%->100%
- 2956: 19/6/17: Compl:0%->50%19/9/17: Compl:50%->100%
- 2957: ¦8/1/18: Compl:0%->77%¦27/3/18: Compl:77%->100%;
- 2959: 21/3/17: Compl:0%->25%¦19/6/17: Compl:25%->80%¦19/9/17: Compl:80%->100%
- 2960: 21/3/17: CD:Thu 15/06/17->Wed 15/03/17
- 2961: ¦8/1/18: Compl:0%->64%27/3/18: Compl:64%->100%;
- 2962: 21/3/17: 36.751 added;
- 2963: 21/3/17: Compl:0%->50%¦19/6/17: Compl:50%->99%¦19/9/17: Compl:99%->100%
- 2964: 19/6/17: Compl:0%->99%19/6/17: CD:Thu 15/06/19/9/17: Compl:99%->100%
- 2965: tested: REL-15 WI LTE_FDD_L_Band-Core27/3/18: Compl: ;; 11/10/20: 60%->100
- 2966: 21/3/17: 36.934 added;¦21/3/17: 36.753 added;
- 2967: 21/3/17: Compl:0%->20%19/6/17: Compl:20%->50%;19/9/17: Compl:50%->100%
- 2968: ¦19/6/17: CD:Thu 15/06/17->Fri 15/09/17 19/9/17: Compl:0%->100%
- 2970: 21/3/17: Compl:0%->5%¦19/6/17: Compl:5%->50%¦19/9/17: Compl:50%->90%¦8/1/18: Compl:90%->100%;
- 2971: tested: REL-15 WI LTE_CA_C_B41_PC2-Core¦27/3/18: Co ;; 28/7/20: 5%->100
- 2973: ¦20/12/16: Compl:0%->15%¦20/12/16: CD:Wed 15/03/17->Thu 15/06/1721/3/17: Compl:15%->70%19/6/17: Compl:70%->99%19/9/17: Compl:99%->100%;

| ID | WBS | Task | Type | Duration | Start | Finish | Complete | Remaining | Total slack | Constraint | Resources | Work | Actual work | Acronym | PCG approved | Impacted TSs and TRs | WI rapporteur name | Release | TSG approved | Status Report |
| --- | --- | --- | --- | --- | --- | --- | --- | --- | --- | --- | --- | --- | --- | --- | --- | --- | --- | --- | --- | --- |
| 2974 | 1221 | **TDD operating band in the L-band for LTE** |  | 197d? | 2016-12-15 A | 2017-09-15 A | 100% |  |  |  |  | 2624h | 2624h | LTE_TDD_L_Band | 38 | 36.753 | Huawei | Rel-15 | 74 |  |
| 2975 | 1221.1 | Core part: TDD operating band in the L-band for LTE |  | 197d? | 2016-12-15 A | 2017-09-15 A | 100% |  |  | finish no earlier than 2017-09-15 | R4 | 1576h | 1576h | LTE_TDD_L_Band-Core | 38 |  | Huawei | Rel-15 | 74 |  |
| 2976 | 1221.2 | Perf. part: TDD operating band in the L-band for LTE |  | 131d? | 2017-03-17 A | 2017-09-15 A | 100% |  |  | finish no earlier than 2017-09-15 | R4 | 1048h | 1048h | LTE_TDD_L_Band-Perf | 38 |  | Huawei | Rel-15 | 74 |  |
| 2977 | 1222 | **Further enhancements to Coordinated Multi-Point (CoMP) Operation for LTE** |  | 393d? | 2017-03-15 A | 2018-09-14 | 99% | 2.13d? | 1951d |  | R1 | 8912h | 7361.02h | feCOMP_LTE | 38 |  | Intel | Rel-15 | 75 |  |
| 2978 | 1222.1 | Core part: Further enhancements to Coordinated Multi-Point (CoMP) Operation for LTE |  | 393d? | 2017-03-15 A | 2018-09-14 | 99% | 3.93d? | 1951d | finish no earlier than 2018-09-15 | R1 | 3144h | 3112.56h | feCOMP_LTE-Core | 38 |  | Intel | Rel-15 | 75 | RP-180318 |
| 2979 | 1222.2 | Perf. part: Further enhancements to Coordinated Multi-Point (CoMP) Operation for LTE |  | 328d? | 2017-03-15 A | 2018-06-15 A | 100% |  |  | finish no earlier than 2018-06-15 | R4 | 2624h | 2624h | feCOMP_LTE-Perf | 38 |  | Intel | Rel-15 | 75 |  |
| 2980 | 1223 | **UE Positioning Accuracy Enhancements for LTE** |  | 393d? | 2017-03-15 A | 2018-09-14 A | 100% |  |  |  | R2 | 8912h | 8912h | LCS_LTE_acc_enh | 38 |  | Nokia | Rel-15 | 75 |  |
| 2981 | 1223.1 | Core part: UE Positioning Accuracy Enhancements for LTE |  | 393d? | 2017-03-15 A | 2018-09-14 A | 100% |  |  | finish no earlier than 2018-09-15 | R2 | 3144h | 3144h | LCS_LTE_acc_enh-Core | 38 |  | Nokia | Rel-15 | 75 | RP-180947 |
| 2982 | 1223.2 | Perf. part: UE Positioning Accuracy Enhancements for LTE |  | 328d? | 2017-03-15 A | 2018-06-15 A | 100% |  |  | finish no earlier than 2018-06-15 | R4 | 2624h | 2624h | LCS_LTE_acc_enh-Perf | 38 |  | Nokia | Rel-15 | 75 |  |
| 2983 | 1224 | **Enhancements for high capacity stationary wireless link and introduction of 1024 QAM for LTE DL** |  | 588d? | 2016-09-14 A | 2018-12-14 | 99% | 2.35d? | 1886d |  | R1 | 11512h | 8083.2h | LTE_1024QAM_DL | 38 |  | Huawei | Rel-15 | 75 |  |
| 2984 | 1224.1 | Core part: Enhancements for high capacity stationary wireless link and introduction of 1024 QAM for LTE DL |  | 393d? | 2017-03-15 A | 2018-09-14 | 99% | 3.93d? | 1951d | finish no earlier than 2018-09-15 | R1 | 3144h | 3112.56h | LTE_1024QAM_DL-Core | 38 | 36.783 | Huawei | Rel-15 | 75 | RP-180854 |
| 2985 | 1224.2 | Perf. part: Enhancements for high capacity stationary wireless link and introduction of 1024 QAM for LTE DL |  | 588d? | 2016-09-14 A | 2018-12-14 A | 100% |  |  | finish no earlier than 2018-12-15 | R4 | 4704h | 4704h | LTE_1024QAM_DL-Perf | 38 |  | Huawei | Rel-15 | 75 |  |
| 2986 | 1225 | **Enhancements to LTE operation in unlicensed spectrum** |  | 458d? | 2017-03-15 A | 2018-12-14 | 99% | 2.74d? | 1886d |  | R1 | 8904h | 5314.36h | LTE_unlic | 38 |  | Nokia | Rel-15 | 75 |  |
| 2987 | 1225.1 | Core part: Enhancements to LTE operation in unlicensed spectrum |  | 393d? | 2017-03-15 A | 2018-09-14 | 99% | 3.93d? | 1951d | finish no earlier than 2018-09-15 | R1 | 3144h | 3112.56h | LTE_unlic-Core | 38 | 37.107; 37.106 | Nokia | Rel-15 | 75 | RP-180948 |
| 2988 | 1225.2 | Perf. part: Enhancements to LTE operation in unlicensed spectrum |  | 262d? | 2017-12-14 A | 2018-12-14 A | 100% |  |  | finish no earlier than 2018-12-15 | R4 | 2096h | 2096h | LTE_unlic-Perf | 38 |  | Nokia | Rel-15 | 75 |  |
| 2989 | 1226 | **Further video enhancements for LTE** |  | 393d? | 2017-03-15 A | 2018-09-14 | 99% | 3.92d? | 1951d |  | R2 | 6288h | 6225.23h | LTE_ViLTE_enh2 | 38 |  | CMCC | Rel-15 | 75 |  |
| 2990 | 1226.1 | Core part: Further video enhancements for LTE |  | 393d? | 2017-03-15 A | 2018-09-14 | 99% | 3.93d? | 1951d | finish no earlier than 2018-09-15 | R2 | 3144h | 3112.56h | LTE_ViLTE_enh2-Core | 38 |  | CMCC | Rel-15 | 75 | RP-172381 |
| 2991 | 1227 | **Quality of Experience (QoE) Measurement Collection for streaming services in E-UTRAN** |  | 458d? | 2017-03-15 A | 2018-12-14 | 99% | 3.04d? | 1886d |  | R2 | 8384h | 7286.39h | LTE_QMC_Streaming | 38 |  | China Unicom | Rel-15 | 75 |  |
| 2992 | 1227.1 | Core part:Quality of Experience (QoE) Measurement Collection for streaming services in E-UTRAN |  | 393d? | 2017-03-15 A | 2018-09-14 | 99% | 3.93d? | 1951d | finish no earlier than 2018-09-15 | R2 | 3144h | 3112.56h | LTE_QMC_Streaming-Core | 38 |  | China Unicom | Rel-15 | 75 | RP-172192 |
| 2993 | 1227.2 | UE Conformance Test Aspects - Quality of Experience (QoE) Measurement Collection for streaming services in E-UTRAN |  | 197d? | 2018-03-15 A | 2018-12-14 A | 100% |  |  | finish no earlier than 2018-12-15 | R5 | 1576h | 1576h | LTE_QMC_Streaming-UEConTest | 40 |  | China Unicom | Rel-15 | 79 |  |
| 2994 | 1228 | **Enhancing LTE CA Utilization** |  | 1171d? | 2017-03-15 A | 2021-09-08 | 97% | 32.06d? | 1173d |  | R2 | 20848h | 11690.4h | LTE_euCA | 38 |  | Nokia | Rel-15 | 75 |  |
| 2995 | 1228.1 | Core part: Enhancing LTE CA Utilization |  | 393d? | 2017-03-15 A | 2018-09-14 | 90% | 39.3d? | 1951d | finish no earlier than 2018-09-15 | R2 | 3144h | 2829.6h | LTE_euCA-Core | 38 |  | Nokia | Rel-15 | 75 | RP-181069 |
| 2996 | 1228.2 | Perf. part: Enhancing LTE CA Utilization |  | 328d? | 2017-09-13 A | 2018-12-14 A | 100% |  |  | finish no earlier than 2018-12-15 | R4 | 2624h | 2624h | LTE_euCA-Perf | 38 |  | Nokia | Rel-15 | 75 |  |
| 2997 | 1228.3 | UE Conformance Test Aspects - Enhancing LTE CA Utilization | manual | 714d | 2018-12-15 A | 2021-09-08 A | 100% |  |  |  | R5 | 5712h | 5712h | LTE_euCA-UEConTest | 42 |  | Nokia | Rel-15 | 82 |  |

Notes:
- 2974: 21/3/17: 36.753 added;¦14/9/17: WID:RP-162557->RP-170304
- 2975: 21/3/17: Compl:0%->15%¦19/6/17: Compl:15%->70%¦ 19/9/17: Compl:70%->100%
- 2976: 21/3/17: WID: RP-162557->RP-170304¦19/6/17: CD:Thu 15/06/17->Fri 15/09/17¦19/9/17: Compl:0%->100%
- 2977: follow-up WI of REL-14 SI FS_feCOMP_LTE completed at RAN #75¦14/9/17: WID:RP-170750->RP-171031
- 2978: follow-up WI of REL-14 SI FS_feCOMP_LTE completed at RAN #75¦19/6/17: Compl:0%->70%¦19/6/17: CD:Fri 15/09/ 19/9/17: Compl:70%->90%¦27/3/18: Compl:90%->99%¦27/3/18: CD:Thu 15/03/18->Fri ¦27/6/18: CD:Fri
- 2979: follow-up WI of REL-14 SI FS_feCOMP_LTE completed at RAN #7519/6/17: WID: RP-170750->RP-171031¦8/1/18: Compl:0%->65%¦8/1/18: CD:Thu 15/03/18->Fri 15/06/1827/3/18: Compl:65%->80%27/3/ ¦27/6/18: Compl:80%->100%
- 2980: 14/9/17: WID:RP-170813->RP-171508
- 2981: ¦19/6/17: Compl:0%->10%¦19/6/17: CD:Fri 15/12/17->Fri 15/06/18 19/9/17: Compl:10%->20%¦8/1/18: Compl:20%->40%¦8/1/18: WID: RP-171508->RP-17231327/3/18: Compl:40%->50%¦27/6/18: Compl:50%->99%;; 24/4/20: 99%->100
- 2982: ¦19/6/17: WID: RP-170813->RP-171508¦8/1/18: Compl:0%->30%¦8/1/18: WID: RP-171508->RP-172313¦27/6/18: Compl:30%->100%¦27/6/18: WID: RP-17231
- 2983: 14/9/17: WID:RP-170838->RP-171067
- 2984: ¦19/6/17: Compl:0%->20%¦19/6/17: CD:Sat 15/12/18->Thu 15/03/18 19/6/17: FCD:03/18->06/18¦12/7/17: 36.783 added;19/9/17: Compl:20%->40%¦8/1/18: Compl:40%->85%27/3/18: Compl:85%->99%
- 2985: ¦19/6/17: CD:Sat 15/12/18->Fri 15/06/18¦19/6/17: WID: RP-170838->RP-171067 19/9/17: WID: RP-171067->RP-17173827/3/18: Compl:0%->25%¦27/6/18: Compl:25%->50%¦16/1/19: 50%->100
- 2986: note: The is actually a further LAA enhancement
- 2987: note: The is actually a further LAA enhancement¦19/6/17: Compl:0%->15%¦19/6/17: CD:Fri 15 19/9/17: Compl:15%->30%¦8/1/18: Compl:30%->65%¦ 27/3/18: Compl:65%->85% 27/3/18: 37.107 added;;
- 2988: 19/6/17: CD:Thu 15/03/18->Sat 15/12/18¦8/1/18: WID: RP-170848->RP-17284127/3/18: WID: RP-172841->RP-180402¦16/1/19: 0%->100
- 2989: no Perf. part¦compare REL-14 WI LTE_VoLTE_ViLTE_enh
- 2990: no Perf. part¦compare REL-14 WI LTE_VoLTE_ViLTE_enh19/6/17: Compl:0%->15%19/6/17: W 19/9/17: Compl:15%->35%¦8/1/18: Compl:35%->99%¦ ¦27/6/18: CD:Fri 15/06/18->Sat 15/09/18
- 2991: compare REL-14 WI UMTS_QMC_Streaming-Core
- 2992: compare REL-14 WI UMTS_QMC_Streaming-Core¦19/6/17: Compl:0%->25%¦19/6/17: WID: RP- 19/9/17: Compl:25%->45%¦8/1/18: Compl:45%->99%¦ ¦27/6/18: CD:Fri 15/06/18->Sat 15/09/18
- 2993: tested: REL-15 WI LTE_QMC_Streaming-Core¦WI code to be used: LTE_QMC_Streaming-UEConTest;; 26/6/19: 5%->100
- 2995: 19/9/17: Compl:0%->22%¦8/1/18: Compl:22%->40%¦16/3/18: FCD:12/17->06/1827/3/18: Compl:40%->60%27/3/18: WID: RP-170805->RP-180561¦27/6/18: Compl:60%->90%;
- 2996: 16/3/18: FCD:12/17->12/18¦27/3/18: WID: RP-170805->RP-180561¦27/6/18: Compl:0%->20%¦26/3/19: 20%->100
- 2997: tested: REL-15 WI LTE_euCA-Core; 8/10/20: 0%->35; 8/10/20: FCD:15/12/2019->12/20; 8/4/21: 0%->56; 8/4/21: FCD:12/12/2020->09/20; 2/7/21: 0%->82; 29/9/21: 0%->100

| ID | WBS | Task | Duration | Start | Finish | Complete | Remaining | Total slack | Constraint | Resources | Work | Actual work | Acronym | PCG approved | WI rapporteur name | Release | TSG approved |
| --- | --- | --- | --- | --- | --- | --- | --- | --- | --- | --- | --- | --- | --- | --- | --- | --- | --- |
| 2998 | 1229 | **450 MHz Band for LTE in Region 3** | 523d? | 2017-03-15 A | 2019-03-15 A | 100% |  |  |  | R4 | 9448h | 9448h | LTE450_Reg3 | 38 | China Unicom | Rel-15 | 75 |
| 2999 | 1229.1 | Core part: 450 MHz Band for LTE in Region 3 | 198d? | 2017-03-15 A | 2017-12-15 A | 100% |  |  | finish no earlier than 2017-12-15 | R4 | 1584h | 1584h | LTE450_Reg3-Core | 38 | China Unicom | Rel-15 | 75 |
| 3000 | 1229.2 | Perf. part: 450 MHz Band for LTE in Region 3 | 198d? | 2017-03-15 A | 2017-12-15 A | 100% |  |  | finish no earlier than 2017-12-15 | R4 | 1584h | 1584h | LTE450_Reg3-Perf | 38 | China Unicom | Rel-15 | 75 |
| 3001 | 1229.3 | UE Conformance Test Aspects - 450 MHz Band for LTE in Region 3 | 262d? | 2018-03-15 A | 2019-03-15 A | 100% |  |  | finish no earlier than 2019-03-15 | R5 | 2096h | 2096h | LTE450_Reg3-UEConTest | 40 | China Unicom, Shi Yu | Rel-15 | 79 |
| 3002 | 1230 | **US 600 MHz Band for LTE** | 198d? | 2017-03-15 A | 2017-12-15 A | 100% |  |  |  | R4 | 4240h | 4240h | LTE600_US | 38 | Ericsson | Rel-15 | 75 |
| 3003 | 1230.1 | Core part: US 600 MHz Band for LTE | 133d? | 2017-03-15 A | 2017-09-15 A | 100% |  |  | finish no earlier than 2017-09-15 | R4 | 1064h | 1064h | LTE600_US-Core | 38 | Ericsson | Rel-15 | 75 |
| 3004 | 1230.2 | Perf. part: US 600 MHz Band for LTE | 133d? | 2017-03-15 A | 2017-09-15 A | 100% |  |  | finish no earlier than 2017-09-15 | R4 | 1064h | 1064h | LTE600_US-Perf | 38 | Ericsson | Rel-15 | 75 |
| 3005 | 1230.3 | UE Conformance Test Aspects - US 600 MHz Band for LTE (Band 71) | 66d? | 2017-09-15 A | 2017-12-15 A | 100% |  |  | finish no earlier than 2018-03-15 | R5 | 528h | 528h | LTE600_US-UEConTest | 39 | Dish Network | Rel-15 | 77 |
| 3006 | 1231 | **LAA/eLAA for the CBRS 3.5GHz band in the United States** | 198d? | 2017-03-15 A | 2017-12-15 A | 100% |  |  |  | R4 | 4752h | 4752h | LTE_3550_CBRS_US_LAA | 38 | AT&T | Rel-15 | 75 |
| 3007 | 1231.1 | Core part: LAA/eLAA for the CBRS 3.5GHz band in the United States | 198d? | 2017-03-15 A | 2017-12-15 A | 100% |  |  | start no earlier than 2017-03-15 | R4 | 1584h | 1584h | LTE_3550_CBRS_US_LAA-Core | 38 | AT&T | Rel-15 | 75 |
| 3008 | 1231.2 | Perf. part: LAA/eLAA for the CBRS 3.5GHz band in the United States | 198d? | 2017-03-15 A | 2017-12-15 A | 100% |  |  | start no earlier than 2017-03-15 | R4 | 1584h | 1584h | LTE_3550_CBRS_US_LAA-Perf | 38 | AT&T | Rel-15 | 75 |
| 3009 | 1232 | **Introduction new band support for 4Rx antenna ports for LTE for REL-15** | 262d? | 2017-06-15 A | 2018-06-15 A | 100% |  |  |  | R4 | 6288h | 6288h | LTE_4Rx_AP_DL_bands_R15 | 39 | Huawei | Rel-15 | 76 |
| 3010 | 1232.1 | Core part: Introduction new band support for 4Rx antenna ports for LTE for REL-15 | 262d? | 2017-06-15 A | 2018-06-15 A | 100% |  |  | finish no earlier than 2018-06-15 | R4 | 2096h | 2096h | LTE_4Rx_AP_DL_bands_R15-Core | 39 | Huawei | Rel-15 | 76 |
| 3011 | 1232.2 | Perf. part: Introduction new band support for 4Rx antenna ports for LTE for REL-15 | 262d? | 2017-06-15 A | 2018-06-15 A | 100% |  |  | finish no earlier than 2018-06-15 | R4 | 2096h | 2096h | LTE_4Rx_AP_DL_bands_R15-Perf | 39 | Huawei | Rel-15 | 76 |
| 3012 | 1233 | **Addition of band 28 and 40 to LTE MTC cat.0** | 67d? | 2017-06-15 A | 2017-09-15 A | 100% |  |  |  | R4 | 1072h | 1072h | LC_MTC_LTE_cat0_B28_B40 | 39 | Huawei | Rel-15 | 76 |
| 3013 | 1233.1 | Core part: Addition of band 28 and 40 to LTE MTC cat.0 | 67d? | 2017-06-15 A | 2017-09-15 A | 100% |  |  | finish no earlier than 2017-09-15 | R4 | 536h | 536h | LC_MTC_LTE_cat0_B28_B40-Core | 39 | Huawei | Rel-15 | 76 |
| 3014 | 1234 | **LTE Advanced high power TDD UE (power class 2) for Rel-15** | 1042d? | 2017-06-15 A | 2021-06-11 A | 100% |  |  |  | R4 | 14048h | 14048h | LTE_TDD_HPUE_R15 | 39 | Huawei | Rel-15 | 76 |
| 3015 | 1234.1 | Core part: LTE Advanced high power TDD UE (power class 2) for Rel-15 | 262d? | 2017-06-15 A | 2018-06-15 A | 100% |  |  | finish no earlier than 2018-06-15 | R4 | 2096h | 2096h | LTE_TDD_HPUE_R15-Core | 39 | Huawei | Rel-15 | 76 |
| 3016 | 1234.2 | UE Conformance Test Aspects – LTE Advanced high power TDD UE (power class 2) for Rel-15 | 452d | 2019-09-19 A | 2021-06-11 A | 100% |  |  | finish no earlier than 2021-06-12 | R5 | 3616h | 3616h | LTE_TDD_HPUE_R15-UEConTest | 43 | Huawei | Rel-15 | 85 |
| 3017 | 1235 | **New LTE band for 3.3-3.4 GHz for Africa** | 196d? | 2017-06-15 A | 2018-03-15 A | 100% |  |  |  | R4 | 4704h | 4704h | LTE_TDD_3300_Africa | 39 | Huawei | Rel-15 | 76 |
| 3018 | 1235.1 | Core part: New LTE band for 3.3-3.4 GHz for Africa | 196d? | 2017-06-15 A | 2018-03-15 A | 100% |  |  | finish no earlier than 2018-03-15 | R4 | 1568h | 1568h | LTE_TDD_3300_Africa-Core | 39 | Huawei | Rel-15 | 76 |
| 3019 | 1235.2 | Perf. part: New LTE band for 3.3-3.4 GHz for Africa | 196d? | 2017-06-15 A | 2018-03-15 A | 100% |  |  | finish no earlier than 2018-03-15 | R4 | 1568h | 1568h | LTE_TDD_3300_Africa-Perf | 39 | Huawei | Rel-15 | 76 |
| 3020 | 1236 | **UE requirements for network-based CRS interference mitigation for LTE** | 392d? | 2017-06-15 A | 2018-12-14 | 93% | 26.74d? | 1886d |  | R4 | 8888h | 8281.69h | LTE_NW_CRS_IM | 39 | Ericsson | Rel-15 | 76 |
| 3021 | 1236.1 | Core part: UE requirements for network-based CRS interference mitigation for LTE | 327d? | 2017-06-15 A | 2018-09-14 | 85% | 49.05d? | 1951d | finish no earlier than 2018-09-15 | R4 | 2616h | 2223.6h | LTE_NW_CRS_IM-Core | 39 | Ericsson | Rel-15 | 76 |
| 3022 | 1236.2 | Perf. part: UE requirements for network-based CRS interference mitigation for LTE | 392d? | 2017-06-15 A | 2018-12-14 A | 100% |  |  | finish no earlier than 2018-12-15 | R4 | 3136h | 3136h | LTE_NW_CRS_IM-Perf | 39 | Ericsson | Rel-15 | 76 |

Notes:
- 2998: 14/9/17: WID:RP-170159->RP-170952
- 2999: ¦19/6/17: Compl:0%->30%¦19 12/7/17: 36.759 added;¦19/9/17: Compl:30%->80%¦8/1/18: Compl:80%->100% / Impacted TSs and TRs: 36.759
- 3000: ¦19/6/17: WID: RP-170159->RP-170952¦8/1/18: Compl:0%->100%
- 3001: ¦27/6/18: Compl:0%->5%;; 14/1/20: 5%->100 / Impacted TSs and TRs: 34.121-1; 36.508; 36.521-1; 36.521-2; 36.521-3; 36.523-2; 36.523-3; 37.571-1; 36.905
- 3003: ¦19/6/17: Compl:0%->95%¦19 12/7/17: 36.755 added;19/9/17: Compl:95%->100% / Impacted TSs and TRs: 36.755
- 3004: ¦19/6/17: Compl:0%->95%¦19 19/9/17: Compl:95%->100%
- 3005: ¦8/1/18: Compl:0%->100%¦
- 3006: compare REL-14 WI LTE_TDD_3550_CBRS_US¦related to LTE band 48, intending a new band definition¦includes 2DL/2UL CA with B2 Acronym changed, was "LTE_TDD_3550_CBRS_US_LAA"
- 3007: compare REL-14 WI LTE_TDD_3550_CBRS_US¦related to LTE band 48, intending a new band definition¦includes 2DL/2UL CA with B2;19/6/17: Com¦Acronym changed, was "LTE_TDD_3550_CBRS_US_LAA-Core"¦12/7/17: 36.790 added;; / Impacted TSs and TRs: 36.790
- 3008: compare REL-14 WI LTE_TDD_3550_CBRS_US¦related to LTE band 48, intending a new band definition¦includes 2DL/2UL CA with B2¦19/6/17: C Acronym changed, was "LTE_TDD_3550_CBRS_US_LAA-Perf";
- 3010: 19/9/17: Compl:0%->99%¦8/1/18: WID: RP-171131->RP-17234727/3/18: Compl:99%->90% ¦27/6/18: Compl:90%->100%
- 3011: ¦8/1/18: WID: RP-171131->RP-172347¦27/3/18: WID: RP-172347->RP-180073¦27/6/18: Compl:0%->100%
- 3013: 19/9/17: Compl:0%->100%
- 3015: 19/9/17: Compl:0%->10%¦ 15/12/17: 36.760 added;¦8/1/18: Compl:10%->40%27/3/18: Compl:40%->99%¦27/6/18: Comp / Impacted TSs and TRs: 36.760
- 3016: 8/10/20: 0%->50; 8/10/20: FCD:15/09/2020->12/20; 8/4/21: 50%->98; 8/4/21: FCD:11/12/2020->06/21; 2/7/21: 98%->100
- 3018: 12/7/17: 36.758 added;19/9/17: Compl:0%->10%¦ 8/1/18: Compl:10%->70%27/3/18: Compl:70%->100%; / Impacted TSs and TRs: 36.758
- 3019: ¦19/9/17: WID: RP-171506->RP-171759¦27/3/18: Compl:0%->100%;
- 3021: ¦19/9/17: Compl:0%->15%¦8/1/18: Compl:15%->50%27/3/18: Compl:50%->70%¦27/6/18: Compl:70%->85%
- 3022: ¦27/6/18: WID: RP-171408->RP-181315¦16/1/19: 0%->100

| ID | WBS | Task | Type | Duration | Start | Finish | Complete | Remaining | Total slack | Constraint | Resources | Work | Actual work | Acronym | PCG approved | WI rapporteur name | Release | TSG approved | Status Report | Impacted TSs and TRs |
| --- | --- | --- | --- | --- | --- | --- | --- | --- | --- | --- | --- | --- | --- | --- | --- | --- | --- | --- | --- | --- |
| 3023 | 1237 | **Bluetooth/WLAN measurement collection in LTE Minimization of Drive Tests (MDT)** |  | 521d? | 2017-12-15 A | 2019-12-15 | 98% | 11.14d? | 1626d |  | R2 | 7832h | 5075.26h | LTE_MDT_BT_WLAN | 40 | CMCC | Rel-15 | 78 |  |  |
| 3024 | 1237.1 | Core part: Bluetooth/WLAN measurement collection in LTE Minimization of Drive Tests (MDT) |  | 196d? | 2017-12-15 A | 2018-09-14 | 95% | 9.8d? | 1951d | finish no earlier than 2018-09-15 | R2 | 1568h | 1489.6h | LTE_MDT_BT_WLAN-Core | 40 | CMCC | Rel-15 | 78 | RP-180867 |  |
| 3025 | 1237.2 | UE Conformance Test Aspects - Bluetooth/WLAN measurement collection in LTE Minimization of Drive Tests (MDT) | manual | 262d | 2018-12-15 A | 2019-12-15 A | 100% |  |  |  | R5 | 2096h | 2096h | LTE_MDT_BT_WLAN-UEConTest | 42 | CMCC | Rel-15 | 82 |  |  |
| 3026 | 1238 | **Enhanced LTE Support for Aerial Vehicles** |  | 591d? | 2017-03-15 A | 2019-06-19 | 99% | 2.19d? | 1753d |  | R2 | 8952h | 7336.69h | LTE_Aerial | 40 | Ericsson | Rel-15 | 78 |  |  |
| 3027 | 1238.1 | Study on enhanced LTE Support for Aerial Vehicles |  | 198d? | 2017-03-15 A | 2017-12-15 A | 100% |  |  | finish no earlier than 2017-12-15 | R2 | 1584h | 1584h | FS_LTE_Aerial | 38 | NTT DOCOMO | Rel-15 | 75 |  | 36.777 |
| 3028 | 1238.2 | Core part: Enhanced LTE Support for Aerial Vehicles |  | 196d? | 2017-12-15 A | 2018-09-14 | 99% | 1.96d? | 1951d | finish no earlier than 2018-09-15 | R2 | 1568h | 1552.32h | LTE_Aerial-Core | 40 | Ericsson | Rel-15 | 78 | RP-181045 |  |
| 3029 | 1238.3 | UE Conformance Test Aspects - Enhanced LTE Support for Aerial Vehicles | manual | 134d | 2018-12-15 A | 2019-06-19 A | 100% |  |  |  | R5 | 1072h | 1072h | LTE_Aerial-UEConTest | 42 | NTT DOCOMO | Rel-15 | 82 |  |  |
| 3030 | 1239 | **Separation of CP and UP for Split Option 2 of NR** |  | 131d? | 2017-12-15 A | 2018-06-15 A | 100% |  |  |  | R3 | 2096h | 2096h | NR_CPUP_Split | 40 | Ericsson | Rel-15 | 78 |  |  |
| 3031 | 1239.1 | Core part: Separation of CP and UP for Split Option 2 of NR |  | 131d? | 2017-12-15 A | 2018-06-15 A | 100% |  |  | finish no earlier than 2018-06-15 | R3 | 1048h | 1048h | NR_CPUP_Split-Core | 40 | Ericsson | Rel-15 | 78 | RP-181149 |  |
| 3032 | 1240 | **UE requirements for LTE DL 8Rx antenna ports** |  | 261d? | 2017-12-15 A | 2018-12-14 A | 100% |  |  |  | R4 | 5224h | 5224h | LTE_8Rx_AP_DL | 40 | Huawei | Rel-15 | 78 |  |  |
| 3033 | 1240.1 | Core part: UE requirements for LTE DL 8Rx antenna ports |  | 131d? | 2017-12-15 A | 2018-06-15 A | 100% |  |  | finish no earlier than 2018-06-15 | R4 | 1048h | 1048h | LTE_8Rx_AP_DL-Core | 40 | Huawei | Rel-15 | 78 | RP-180959 |  |
| 3034 | 1240.2 | Perf. part: UE requirements for LTE DL 8Rx antenna ports |  | 261d? | 2017-12-15 A | 2018-12-14 A | 100% |  |  | finish no earlier than 2018-12-15 | R4 | 2088h | 2088h | LTE_8Rx_AP_DL-Perf | 40 | Huawei | Rel-15 | 78 |  |  |
| 3035 | 1241 | **ProSe Support for Band 72 in LTE** |  | 261d? | 2017-12-15 A | 2018-12-14 A | 100% |  |  |  | R4 | 2624h | 2624h | LTE450_B72_Europe_ProSe | 40 | Airbus | Rel-15 | 78 |  |  |
| 3036 | 1241.1 | Core part: ProSe Support for Band 72 in LTE |  | 1d? | 2017-12-15 A | 2017-12-15 A | 100% |  |  | finish no earlier than 2017-12-15 | R4 | 8h | 8h | LTE450_B72_Europe_ProSe-Core | 40 | Airbus | Rel-15 | 78 |  |  |
| 3037 | 1241.2 | UE Conformance Test Aspects - ProSe Support for Band 72 in LTE |  | 66d? | 2018-09-14 A | 2018-12-14 A | 100% |  |  | finish no earlier than 2018-12-14 | R5 | 528h | 528h | LTE450_B72_Europe_ProSe-UEConTest | 41 | Airbus | Rel-15 | 81 |  |  |
| 3038 | 1242 | **LTE Advanced inter-band CA Rel-15 for xDL/1UL with x>5** |  | 261d? | 2017-12-15 A | 2018-12-14 A | 100% |  |  |  | R4 | 5224h | 5224h | LTE_CA_R15_xDL1UL | 40 | Qualcomm | Rel-15 | 78 |  |  |
| 3039 | 1242.1 | Core part:LTE Advanced inter-band CA Rel-15 for xDL/1UL with x>5 |  | 131d? | 2017-12-15 A | 2018-06-15 A | 100% |  |  | finish no earlier than 2018-06-15 | R4 | 1048h | 1048h | LTE_CA_R15_xDL1UL-Core | 40 | Qualcomm | Rel-15 | 78 |  | 36.715-00-01 |
| 3040 | 1242.2 | Perf. part:LTE Advanced inter-band CA Rel-15 for xDL/1UL with x>5 |  | 261d? | 2017-12-15 A | 2018-12-14 A | 100% |  |  | finish no earlier than 2018-12-15 | R4 | 2088h | 2088h | LTE_CA_R15_xDL1UL-Perf | 40 | Qualcomm | Rel-15 | 78 |  |  |
| 3041 | 1243 | **Performance requirements of interference cancellation receiver for LTE BS** |  | 67d? | 2017-06-15 A | 2017-09-15 A | 100% |  |  |  | R4 | 1072h | 1072h | LTE_IC_BS | 39 | China Telecom | Rel-15 | 76 |  |  |
| 3042 | 1243.1 | Perf. part: Performance requirements of interference cancellation receiver for LTE BS |  | 67d? | 2017-06-15 A | 2017-09-15 A | 100% |  |  | finish no earlier than 2017-09-15 | R4 | 536h | 536h | LTE_IC_BS-Perf | 39 | China Telecom | Rel-15 | 76 |  |  |
| 3043 | 1244 | **LTE CRS-Interference Mitigation performance requirements for single RX chain UEs** |  | 262d? | 2017-06-15 A | 2018-06-15 A | 100% |  |  |  | R4 | 4192h | 4192h | LTE_1RX_CRS_IM | 39 | Intel | Rel-15 | 76 |  |  |
| 3044 | 1244.1 | Perf. part: LTE CRS-Interference Mitigation performance requirements for single RX chain UEs |  | 262d? | 2017-06-15 A | 2018-06-15 A | 100% |  |  | finish no earlier than 2018-06-15 | R4 | 2096h | 2096h | LTE_1RX_CRS_IM-Perf | 39 | Intel | Rel-15 | 76 |  |  |
| 3045 | 1245 | **LTE Advanced intra-band CA Rel-15 for xDL/yUL including contiguous and non-contiguous spectrum** |  | 262d? | 2017-06-15 A | 2018-06-15 A | 100% |  |  |  | R4 | 6288h | 6288h | LTE_CA_R15_intra | 39 | Ericsson | Rel-15 | 76 |  |  |
| 3046 | 1245.1 | Core part: LTE Advanced intra-band CA Rel-15 for xDL/yUL including contiguous and non-contiguous spectrum |  | 262d? | 2017-06-15 A | 2018-06-15 A | 100% |  |  | finish no earlier than 2018-06-15 | R4 | 2096h | 2096h | LTE_CA_R15_intra-Core | 39 | Ericsson | Rel-15 | 76 |  | 36.715-00-00 |
| 3047 | 1245.2 | Perf. part: LTE Advanced intra-band CA Rel-15 for xDL/yUL including contiguous and non-contiguous spectrum |  | 262d? | 2017-06-15 A | 2018-06-15 A | 100% |  |  | finish no earlier than 2018-06-15 | R4 | 2096h | 2096h | LTE_CA_R15_intra-Perf | 39 | Ericsson | Rel-15 | 76 |  |  |

Notes:
- 3023: MDT = Minimization of Drive Tests¦no Perf. part¦may have SA5 impact
- 3024: MDT = Minimization of Drive Tests¦no Perf. part¦may have SA5 impact27/3/18: Compl:0%->30%2 ¦27/6/18: Compl:30%->95%
- 3025: tested: REL-15 WI LTE_MDT_BT_WLAN-Core; 14/1/20: 0%->100; 14/1/20: 100%->100
- 3026: follow-up WI of REL-15 SI FS_LTE_Aerial¦no Perf. part
- 3027: TR 36.7XX19/6/17: Compl:0%->15%¦30/6/17: 36.777 added;¦19/9/17: Compl:15%->30%¦8/1/18: Compl:30%->100%
- 3028: follow-up WI of REL-15 SI FS_LTE_Aerial¦no Perf. part¦27/3/18: Compl:0%->15%¦27/6/18: Compl:15%->99%;
- 3029: tested: REL-15 WI LTE_Aerial-Core; 8/10/19: WID:RP-182324->RP-191747; 14/1/20: WID:RP-191747->RP-192747; 14/1/20: 0%->100
- 3030: follow-up WI of REL-15 SI FS_NR_CPUP_Split¦introduction of E1 interface
- 3031: follow-up WI of REL-15 SI FS_NR_CPUP_Split¦introduction of E1 interface. 30/1/18: acronym updated27/3/18: Compl:0%->30%27/3/18: WID: RP-172831->RP-180326¦27/6/18: Compl:30%->100%¦27/6/18: Stat Rep: ->RP-181149
- 3032: follow-up WI of REL-15 SI FS_LTE_8Rx_AP_DL
- 3033: follow-up WI of REL-15 SI FS_LTE_8Rx_AP_DL27/3/18: Compl:0%->40%¦27/6/18: Compl:40%->100%
- 3034: follow-up WI of REL-15 SI FS_LTE_8Rx_AP_DL¦27/6/18: Compl:0%->30%¦26/3/19: 30%->100
- 3035: This WI was opened, a RAN4 CR RP-172572 was approved and the WI was completed all at RAN #78¦compare REL-15 WI LTE450_Europe_PPDR-Core¦16/1/19: WID:RP-172568->RP-182441
- 3036: This WI was opened, a RAN4 CR RP-172572 was approved and the WI was completed all at RAN #78¦compare REL-15 WI LTE450_Europe_PPDR-Core;
- 3037: 16/1/19: 0%->100
- 3038: basket CA WI¦TR 36.715-00-01
- 3039: basket CA WI¦TR 36.715-00-01¦27/3/18: Compl:0%->10%¦27/3/18: 36.715-00-01 added;¦27/6/18: Compl:10%->100%;
- 3040: basket CA WI27/3/18: CD:Sat 15/12/18->Fri 15/06/18 ¦27/6/18: Compl:0%->50%;¦16/1/19: 50%->100
- 3042: ¦19/9/17: Compl:0%->100%
- 3044: ¦19/9/17: Compl:0%->20%¦19/9/17: WID: RP-171465->RP-171831¦8/1/18: Compl:20%->60%¦27/3/18: Compl:60%->85%¦27/6/18: Compl:85%->100%
- 3046: 12/7/17: 36.715-00-00 added;¦19/9/17: Compl:0%->25% 8/1/18: Compl:25%->70%;27/3/18: Compl:70%->67%¦ ¦27/6/18: Compl:67%->100%;
- 3047: 19/9/17: Compl:0%->25%¦ 8/1/18: Compl:25%->70%¦8/1/18:27/3/18: Compl:70%->67%¦ ¦27/6/18: Compl:67%->100%;

| ID | WBS | Task | Duration | Start | Finish | Complete | Remaining | Baseline start | Baseline finish | Baseline duration | Total slack | Constraint | Resources | Work | Actual work | Acronym | PCG approved | WI rapporteur name | Release | TSG approved | Impacted TSs and TRs | WI rapporteur e-mail | Status Report | MCC resp | TSG stopped | Acronym_3GU_Export |
| --- | --- | --- | --- | --- | --- | --- | --- | --- | --- | --- | --- | --- | --- | --- | --- | --- | --- | --- | --- | --- | --- | --- | --- | --- | --- | --- |
| 3048 | 1246 | **LTE Advanced inter-band CA Rel-15 for 2DL/1UL** | 262d? | 2017-06-15 A | 2018-06-15 A | 100% |  |  |  |  |  |  | R4 | 6288h | 6288h | LTE_CA_R15_2DL1UL | 39 | Qualcomm | Rel-15 | 76 |  |  |  |  |  |  |
| 3049 | 1246.1 | Core part:LTE Advanced inter-band CA Rel-15 for 2DL/1UL | 262d? | 2017-06-15 A | 2018-06-15 A | 100% |  |  |  |  |  | finish no earlier than 2018-06-15 | R4 | 2096h | 2096h | LTE_CA_R15_2DL1UL-Core | 39 | Qualcomm | Rel-15 | 76 | 36.715-02-01 |  |  |  |  |  |
| 3050 | 1246.2 | Perf. part:LTE Advanced inter-band CA Rel-15 for 2DL/1UL | 262d? | 2017-06-15 A | 2018-06-15 A | 100% |  |  |  |  |  | finish no earlier than 2018-06-15 | R4 | 2096h | 2096h | LTE_CA_R15_2DL1UL-Perf | 39 | Qualcomm | Rel-15 | 76 |  |  |  |  |  |  |
| 3051 | 1247 | **LTE Advanced inter-band CA Rel-15 for 3DL/1UL** | 262d? | 2017-06-15 A | 2018-06-15 A | 100% |  |  |  |  |  |  | R4 | 6288h | 6288h | LTE_CA_R15_3DL1UL | 39 | Huawei | Rel-15 | 76 |  |  |  |  |  |  |
| 3052 | 1247.1 | Core part:LTE Advanced inter-band CA Rel-15 for 3DL/1UL | 262d? | 2017-06-15 A | 2018-06-15 A | 100% |  |  |  |  |  | finish no earlier than 2018-06-15 | R4 | 2096h | 2096h | LTE_CA_R15_3DL1UL-Core | 39 | Huawei | Rel-15 | 76 | 36.715-03-01 |  |  |  |  |  |
| 3053 | 1247.2 | Perf. part:LTE Advanced inter-band CA Rel-15 for 3DL/1UL | 262d? | 2017-06-15 A | 2018-06-15 A | 100% |  |  |  |  |  | finish no earlier than 2018-06-15 | R4 | 2096h | 2096h | LTE_CA_R15_3DL1UL-Perf | 39 | Huawei | Rel-15 | 76 |  |  |  |  |  |  |
| 3054 | 1248 | **LTE Advanced inter-band CA Rel-15 for 4DL/1UL** | 262d? | 2017-06-15 A | 2018-06-15 A | 100% |  |  |  |  |  |  | R4 | 6288h | 6288h | LTE_CA_R15_4DL1UL | 39 | Ericsson | Rel-15 | 76 |  |  |  |  |  |  |
| 3055 | 1248.1 | Core part:LTE Advanced inter-band CA Rel-15 for 4DL/1UL | 262d? | 2017-06-15 A | 2018-06-15 A | 100% |  |  |  |  |  | finish no earlier than 2018-06-15 | R4 | 2096h | 2096h | LTE_CA_R15_4DL1UL-Core | 39 | Ericsson | Rel-15 | 76 | 36.715-04-01 |  |  |  |  |  |
| 3056 | 1248.2 | Perf. part:LTE Advanced inter-band CA Rel-15 for 4DL/1UL | 262d? | 2017-06-15 A | 2018-06-15 A | 100% |  |  |  |  |  | finish no earlier than 2018-06-15 | R4 | 2096h | 2096h | LTE_CA_R15_4DL1UL-Perf | 39 | Ericsson | Rel-15 | 76 |  |  |  |  |  |  |
| 3057 | 1249 | **LTE Advanced inter-band CA Rel-15 for 5DL/1UL** | 262d? | 2017-06-15 A | 2018-06-15 A | 100% |  |  |  |  |  |  | R4 | 6288h | 6288h | LTE_CA_R15_5DL1UL | 39 | Nokia | Rel-15 | 76 |  |  |  |  |  |  |
| 3058 | 1249.1 | Core part:LTE Advanced inter-band CA Rel-15 for 5DL/1UL | 262d? | 2017-06-15 A | 2018-06-15 A | 100% |  |  |  |  |  | finish no earlier than 2018-06-15 | R4 | 2096h | 2096h | LTE_CA_R15_5DL1UL-Core | 39 | Nokia | Rel-15 | 76 | 36.715-05-01 |  |  |  |  |  |
| 3059 | 1249.2 | Perf. part:LTE Advanced inter-band CA Rel-15 for 5DL/1UL | 262d? | 2017-06-15 A | 2018-06-15 A | 100% |  |  |  |  |  | finish no earlier than 2018-06-15 | R4 | 2096h | 2096h | LTE_CA_R15_5DL1UL-Perf | 39 | Nokia | Rel-15 | 76 |  |  |  |  |  |  |
| 3060 | 1250 | **LTE Advanced inter-band CA Rel-15 for 2DL/2UL** | 262d? | 2017-06-15 A | 2018-06-15 A | 100% |  |  |  |  |  |  | R4 | 6288h | 6288h | LTE_CA_R15_2DL2UL | 39 | Huawei | Rel-15 | 76 |  |  |  |  |  |  |
| 3061 | 1250.1 | Core part:LTE Advanced inter-band CA Rel-15 for 2DL/2UL | 262d? | 2017-06-15 A | 2018-06-15 A | 100% |  |  |  |  |  | finish no earlier than 2018-06-15 | R4 | 2096h | 2096h | LTE_CA_R15_2DL2UL-Core | 39 | Huawei | Rel-15 | 76 | 36.715-02-02 |  |  |  |  |  |
| 3062 | 1250.2 | Perf. part:LTE Advanced inter-band CA Rel-15 for 2DL/2UL | 262d? | 2017-06-15 A | 2018-06-15 A | 100% |  |  |  |  |  | finish no earlier than 2018-06-15 | R4 | 2096h | 2096h | LTE_CA_R15_2DL2UL-Perf | 39 | Huawei | Rel-15 | 76 |  |  |  |  |  |  |
| 3063 | 1251 | **LTE Advanced inter-band CA Rel-15 for xDL/2UL with x=3,4,5** | 262d? | 2017-06-15 A | 2018-06-15 A | 100% |  |  |  |  |  |  | R4 | 6288h | 6288h | LTE_CA_R15_xDL2UL | 39 | LG Electronics | Rel-15 | 76 |  |  |  |  |  |  |
| 3064 | 1251.1 | Core part:LTE Advanced inter-band CA Rel-15 for xDL/2UL with x=3,4,5 | 262d? | 2017-06-15 A | 2018-06-15 A | 100% |  |  |  |  |  | finish no earlier than 2018-06-15 | R4 | 2096h | 2096h | LTE_CA_R15_xDL2UL-Core | 39 | LG Electronics | Rel-15 | 76 | 36.715-00-02 |  |  |  |  |  |
| 3065 | 1251.2 | Perf. part:LTE Advanced inter-band CA Rel-15 for xDL/2UL with x=3,4,5 | 262d? | 2017-06-15 A | 2018-06-15 A | 100% |  |  |  |  |  | finish no earlier than 2018-06-15 | R4 | 2096h | 2096h | LTE_CA_R15_xDL2UL-Perf | 39 | LG Electronics | Rel-15 | 76 |  |  |  |  |  |  |
| 3066 | 1252 | UE Conformance Test Aspects – Rel-15 CA configurations | 1360d? | 2017-09-15 A | 2022-12-01 A | 100% |  |  |  |  |  | finish no earlier than 2022-12-01 | R5 | 10880h | 10880h | LTE_CA_R15-UEConTest | 39 | Leif MATTISSON, Ericsson | Rel-15 | 77 |  | Leif[dot]mattisson[at]ericsson[dot]com | RP-222814 |  |  |  |
| 3067 | 1253 | **Stopped - LTE UE Total Radiated Power (TRP) and Total Radiated Sensitivity (TRS) and UTRA Hand Phantom related UE TRP and TRS Requirements** | 1315d? | 2012-12-15 A | 2017-12-15 | 82% | 237.87d? | 2013-03-15 | 2015-06-12 | 591d? | 2146d |  |  | 17816h | 14593.1h | LTE_UTRA_TRP_TRS | 30 | Nokia | Rel-15 | 58 | UTRA; LTE | petri.j.vasenkari@nokia.com |  | Issam | 80 | LTE_UTRA_TRP_TRS |
| 3068 | 1253.1 | Stopped - Core part: LTE UE TRP and TRS and UTRA Hand Phantom related UE TRP and TRS Requirements | 1244d? | 2012-12-15 A | 2017-12-15 | 85% | 186.6d? | 2013-03-15 | 2014-09-12 | 393d? | 2146d | finish no earlier than 2017-12-15 | R4 | 9952h | 8459.2h | LTE_UTRA_TRP_TRS-Core | 30 | Nokia | Rel-15 | 58 | 25.144; New 37.144 | petri.j.vasenkari@nokia.com |  | Issam | 80 | LTE_UTRA_TRP_TRS-Core |
| 3069 | 1253.2 | Stopped - Test part: LTE UE TRP and TRS and UTRA Hand Phantom | 983d? | 2014-03-15 A | 2017-12-15 | 78% | 216.26d? | 2014-03-06 | 2015-06-12 | 332d? | 2146d | finish no earlier than 2017-12-15 | R5 | 7864h | 6133.92h | LTE_UTRA_TRP_TRS-UEConTest | 32 | ZTE | Rel-15 | 63 | New 37.544 | TAYLOR Carolyn (carolyn.tayl@zte.com.cn) |  | Ingbert | 80 | LTE_UTRA_TRP_TRS-UEConTest |
| 3070 | 1254 | **Further enhancements for Extended Coverage GSM for support of Cellular Internet of Things** | 132d? | 2018-03-15 A | 2018-09-14 | 90% | 13.2d? |  |  |  | 1951d |  | R6 | 3168h | 2115.17h | CIoT_EC_GSM_fenh | 40 | Nokia | Rel-15 | 79 |  |  |  |  |  |  |
| 3071 | 1254.1 | Core part: Further enhancements for Extended Coverage GSM for support of Cellular Internet of Things | 132d? | 2018-03-15 A | 2018-09-14 | 80% | 26.4d? |  |  |  | 1951d | finish no earlier than 2018-09-15 | R6 | 1056h | 844.8h | CIoT_EC_GSM_fenh-Core | 40 | Nokia | Rel-15 | 79 |  |  |  |  |  |  |
| 3072 | 1254.2 | Perf. part: Further enhancements for Extended Coverage GSM for support of Cellular Internet of Things | 132d? | 2018-03-15 A | 2018-09-14 A | 100% |  |  |  |  |  | finish no earlier than 2018-09-15 | R6 | 1056h | 1056h | CIoT_EC_GSM_fenh-Perf | 40 | Nokia | Rel-15 | 79 |  |  |  |  |  |  |

Notes:
- 3049: 12/7/17: 36.715-02-01 added;19/9/17: Compl:0%->20%¦ 8/1/18: Compl:20%->30%¦27/3/18: Compl:30%->40%¦ ¦27/6/18: Compl:40%->100%;
- 3050: ¦19/9/17: Compl:0%->20% 8/1/18: Compl:20%->30%;27/3/18: Compl:30%->40% ¦27/6/18: Compl:40%->100%;
- 3052: 12/7/17: 36.715-03-01 added;¦19/9/17: Compl:0%->20%¦ 8/1/18: Compl:20%->40%¦27/3/18: Compl:40%->65%¦ ¦27/6/18: Compl:65%->100%;
- 3053: ¦19/9/17: Compl:0%->20%¦ 8/1/18: Compl:20%->40%;27/3/18: Compl:40%->65%¦ ¦27/6/18: Compl:65%->100%;
- 3055: 12/7/17: 36.715-04-01 added;¦19/9/17: Compl:0%->54% 8/1/18: Compl:54%->65%;27/3/18: Compl:65%->63% ¦27/6/18: Compl:63%->100%;
- 3056: 19/9/17: Compl:0%->54%¦ 8/1/18: Compl:54%->65%¦27/3/18: Compl:65%->63% ¦27/6/18: Compl:63%->100%;
- 3058: 12/7/17: 36.715-05-01 added;19/9/17: Compl:0%->20%¦ 8/1/18: Compl:20%->50%;27/3/18: Compl:50%->75% ¦27/6/18: Compl:75%->100%;
- 3059: ¦19/9/17: Compl:0%->20% 8/1/18: Compl:20%->50%¦27/3/18: Compl:50%->75%¦ ¦27/6/18: Compl:75%->100%;
- 3061: 12/7/17: 36.715-02-02 added;¦19/9/17: Compl:0%->20%¦ 8/1/18: Compl:20%->40%;27/3/18: Compl:40%->60%¦27/6/18: Compl:60%
- 3062: ¦19/9/17: Compl:0%->20%¦ 8/1/18: Compl:20%->40%;27/3/18: Compl:40%->60%¦27/6/18: Compl:60%->100%
- 3064: 12/7/17: 36.715-00-02 added;¦19/9/17: Compl:0%->20% 8/1/18: Compl:20%->50%¦27/3/18: Compl:50%->80%¦ ¦27/6/18:
- 3065: 19/9/17: CD:Sat 15/09/18->Fri 15/06/18¦ 8/1/18: Compl:0%->50%¦27/3/18: Compl:50%->80% ¦27/6/18: Compl:80%->100%;
- 3066: ¦8/1/18: Compl:0%->7%¦27/3/18: Compl:7%->8% ;; 8/10/20: 9%->22; 8/10/20: FCD:14/06/2019->12/20; 8/4/21: FCD:11/12/2020->09/21; 8/4/21: 22%->22; 2/7/21: FCD:Wed 08/09/->03/22; 2/7/21: 22%->24; ; 20/6/22: Rapporteur: Ericsson->Leif MATTISSON, Er...;...; 9/1/23: 100%->100
- 3067: Triggered by Rel-11 TR 37.902 Study on Measurements of radio performances for LTE terminals - TRP and TRS test methodology (FS_LTE_OTA) UID_550022
- 3068: ¦CD:Wed 18/03/15->Sun 15/03/15¦Rel-12->Rel-13¦Stat Rep: RP-141158->RP-141973 1st Apr 15: Compl:35%->40% 1st Apr 15: Stat Rep: RP-141973->RP-150104 03/07/15: Stat Rep: RP-150104->RP-150615 29/09/15: Compl:40%->50% 29/09/15: Stat Rep: RP-150615->RP-15
- 3069: Stat Rep: RP-141132->RP-141848¦Rel 12->Rel13 1st Apr 15: Compl:15%->20% 1st Apr 15: CD:Mon 15/06/15->Wed 15/06/16 1st Apr 15: WID: RP-140090->RP-150070 1st Apr 15: Stat Rep: RP-141848->RP-150069 03/07/15: Compl:20%->25% 03/07/15: Stat Rep: RP-150069->
- 3070: follow-up WI of REL-14 WI CIoT_EC_GSM_radio_enh
- 3071: follow-up WI of REL-14 WI CIoT_EC_GSM_radio_enh¦27/6/18: Compl:0%->80%;
- 3072: follow-up WI of REL-14 WI CIoT_EC_GSM_radio_enh¦27/6/18: Compl:0%->80%;¦10/9/18: 80%->100

| ID | WBS | Task | Type | Duration | Start | Finish | Complete | Baseline start | Baseline finish | Baseline duration | Constraint | Resources | Work | Actual work | Acronym | PCG approved | WI rapporteur name | Release | TSG approved | Impacted TSs and TRs | WI rapporteur e-mail | TSG stopped | Status Report | MCC resp | Acronym_3GU_Export |
| --- | --- | --- | --- | --- | --- | --- | --- | --- | --- | --- | --- | --- | --- | --- | --- | --- | --- | --- | --- | --- | --- | --- | --- | --- | --- |
| 3073 | 1255 | **LTE Advanced inter-band CA Rel-15 for xDL/3UL with x=3,4,5** |  | 67d? | 2018-03-15 A | 2018-06-15 A | 100% |  |  |  |  | R4 | 1072h | 1072h | LTE_CA_R15_xDL3UL | 40 | KDDI | Rel-15 | 79 |  |  |  |  |  |  |
| 3074 | 1255.1 | Core part: LTE Advanced inter-band CA Rel-15 for xDL/3UL with x=3,4,5 |  | 67d? | 2018-03-15 A | 2018-06-15 A | 100% |  |  |  | finish no earlier than 2018-06-15 | R4 | 536h | 536h | LTE_CA_R15_xDL3UL-Core | 40 | KDDI | Rel-15 | 79 |  |  |  |  |  |  |
| 3075 | 1255.2 | Perf. Part: LTE Advanced inter-band CA Rel-15 for xDL/3UL with x=3,4,5 | milestone | 0d? | 2018-05-15 A | 2018-05-15 A | 100% |  |  |  | finish no earlier than 2018-06-15 | R4 |  |  | LTE_CA_R15_xDL3UL-Perf | 41 | KDDI | Rel-15 | 80 |  |  |  |  |  |  |
| 3076 | 1256 | **Addition of Power Class 1 UE to bands B31/B72 for LTE** |  | 197d? | 2018-03-15 A | 2018-12-14 A | 100% |  |  |  |  | R4 | 2640h | 2640h | LTE_PC1_B31_B72 | 40 | Airbus | Rel-15 | 79 |  |  |  |  |  |  |
| 3077 | 1256.1 | Core part: Addition of Power Class 1 UE to bands B31/B72 for LTE |  | 67d? | 2018-03-15 A | 2018-06-15 A | 100% |  |  |  | finish no earlier than 2018-12-15 | R4 | 536h | 536h | LTE_PC1_B31_B72-Core | 40 | Airbus | Rel-15 | 79 |  |  |  |  |  |  |
| 3078 | 1256.2 | UE Conformance Test Aspects - Addition of Power Class 1 UE to bands B31/B72 for LTE |  | 66d? | 2018-09-14 A | 2018-12-14 A | 100% |  |  |  | finish no earlier than 2018-12-14 | R5 | 528h | 528h | LTE_PC1_B31_B72-UEConTest |  | Airbus | Rel-15 |  |  |  |  |  |  |  |
| 3079 | 1257 | Release 15 Studies | milestone | 0d? | 2016-06-09 A | 2016-06-09 A | 100% |  |  |  | finish no earlier than 2016-06-09 |  |  |  |  |  |  | Rel-15 |  |  |  |  |  |  |  |
| 3080 | 1258 | Release 15 Studies on 5G | milestone | 0d? | 2016-06-09 A | 2016-06-09 A | 100% |  |  |  | finish no earlier than 2016-06-09 |  |  |  |  |  |  | Rel-15 |  |  |  |  |  |  |  |
| 3081 | 1259 | Study on management aspects of virtualized network functions that are part of the NR |  | 325d? | 2016-09-19 A | 2017-12-15 A | 100% |  |  |  | finish no earlier than 2017-12-15 | S5 | 2600h | 2600h | FS_MA_RNVNF | 37 | Intel (Joey Chou | Rel-15 | 73 | 32.864 | joey.chou@intel.com |  |  |  |  |
| 3082 | 1260 | Study on CU-DU lower layer split for New Radio |  | 328d? | 2017-03-15 A | 2018-06-15 A | 100% |  |  |  | finish no earlier than 2018-06-15 | R3 | 2624h | 2624h | FS_NR_CU_DU_LLS | 38 | NTT DOCOMO | Rel-15 | 75 | 38.816 |  |  |  |  |  |
| 3083 | 1261 | Study on NR to support non-terrestrial networks |  | 328d? | 2017-03-15 A | 2018-06-15 A | 100% |  |  |  | finish no earlier than 2018-06-15 | R1 | 2624h | 2624h | FS_NR_nonterr_nw | 38 | Thales | Rel-15 | 75 | 38.811 |  |  |  |  |  |
| 3084 | 1262 | STOPPED AT SA#77 - SA3 aspects on Study on Architecture and Security for Next Generation System |  | 467d? | 2016-03-01 A | 2017-12-12 A | 100% |  |  |  | finish no earlier than 2017-12-12 | S3 | 3736h | 3736h | FS_NSA | 36 | Vesa Torvinen, Ericsson | Rel-15 | 71 | 33.899 | vesa.torvinen@ericsson.com |  |  |  |  |
| 3085 | 1263 | Study on separation of CP and UP for split option 2 of NR |  | 132d? | 2017-06-15 A | 2017-12-15 A | 100% |  |  |  | finish no earlier than 2017-12-15 | R3 | 1056h | 1056h | FS_NR_CPUP_Split | 39 | Ericsson | Rel-15 | 76 | 38.806 |  |  |  |  |  |
| 3086 | 1264 | Release 15 Studies on 4G/LTE | milestone | 0d? | 2016-06-09 A | 2016-06-09 A | 100% |  |  |  | finish no earlier than 2016-06-09 |  |  |  |  |  |  | Rel-15 |  |  |  |  |  |  |  |
| 3087 | 1265 | Stopped - Study on LTE bandwidth flexibility enhancements |  | 263d? | 2016-03-15 A | 2017-03-15 A | 100% |  |  |  | finish no earlier than 2017-03-15 | R4 | 2104h | 2104h | FS_LTE_BW_flex | 36 | Huawei | Rel-15 | 71 | 36.740 |  | 80 |  |  |  |
| 3088 | 1266 | Study on interference cancellation receiver for LTE BS |  | 196d? | 2016-09-15 A | 2017-06-15 A | 100% |  |  |  | finish no earlier than 2017-06-15 | R4 | 1568h | 1568h | FS_LTE_IC_BS | 37 | China Telecom | Rel-15 | 73 | 36.766 |  |  |  |  |  |
| 3089 | 1267 | Study on uplink data compression in LTE |  | 197d? | 2016-12-15 A | 2017-09-15 A | 100% |  |  |  | finish no earlier than 2017-09-15 | R2 | 1576h | 1576h | FS_LTE_UDC | 38 | CATT | Rel-15 | 74 | 36.754 |  |  |  |  |  |
| 3090 | 1268 | Study on LTE DL 8Rx antenna ports |  | 132d? | 2017-06-15 A | 2017-12-15 A | 100% |  |  |  | finish no earlier than 2017-12-15 | R4 | 1056h | 1056h | FS_LTE_8Rx_AP_DL | 39 | Huawei | Rel-15 | 76 | 36.757 |  |  |  |  |  |
| 3091 | 1269 | Other Release 15 Studies |  | 136d? | 2017-09-08 A | 2018-03-16 A | 100% |  |  |  | finish no earlier than 2018-03-16 |  |  |  |  |  |  | Rel-15 |  |  |  |  |  |  |  |
| 3092 | 1270 | Study on Update to fixed-point basic operators |  | 135d? | 2017-09-08 A | 2018-03-15 A | 100% |  |  |  | finish no earlier than 2018-03-15 | S4 | 1080h | 1080h | FS_BASOP | 39 | Jelinek, Milan, VoiceAge Corporation | Rel-15 | 77 | New; 26.973 | Milan.Jelinek@USherbrooke.ca |  |  |  |  |
| 3093 | 1271 | Study on further enhancements to LTE Device to Device (D2D), UE to network relays for IoT (Internet of Things) and wearables |  | 460d? | 2016-03-15 A | 2017-12-15 A | 100% |  |  |  | finish no earlier than 2017-12-15 | R2 | 3680h | 3680h | FS_feD2D_IoT_relay_wearable | 36 | Qualcomm | Rel-15 | 71 | 36.746 |  |  |  |  |  |
| 3094 | 1272 | Study on Energy Efficiency Aspects of 3GPP Standards |  | 327d? | 2016-03-11 A | 2017-06-09 A | 100% |  |  |  | finish no earlier than 2017-06-09 | SP | 2616h | 2616h | FS_ENEFF | 36 | Orange, Xiaobao Chen | Rel-15 | 71 | 21.866 | xiaobao.chen@orange.com |  | _SP-170533 |  |  |
| 3095 | 1273 | Study on evaluation methodology of new V2X use cases for LTE and NR |  | 328d? | 2017-03-15 A | 2018-06-15 A | 100% |  |  |  | finish no earlier than 2018-06-15 | R1 | 2624h | 2624h | FS_LTE_NR_V2X_eval | 38 | LG Electronics | Rel-15 | 75 | 37.885 |  |  |  |  |  |
| 3096 | 1274 | Study on FEC for MC Services |  | 204d? | 2017-06-05 A | 2018-03-15 A | 100% |  |  |  | finish no earlier than 2018-03-15 | S4 | 1632h | 1632h | FS_FEC_MCS | 39 | Lambrou, John - Motorola Solutions | Rel-15 | 76 | 26.881 | john (dot) lambrou (at) motorolasolutions (dot) com |  |  |  |  |
| 3097 | 1275 | Study on Enhanced Isolated E-UTRAN Operation for Public Safety |  | 205d? | 2016-03-07 A | 2016-12-15 A | 100% |  |  |  | finish no earlier than 2016-12-15 | S2 | 1640h | 1640h | FS_IOPS_LB | 36 | Antoine Mouquet, Orange | Rel-15 | 71 | 23.798 | antoine.mouquet@orange.com |  |  |  |  |
| 3098 | 1276 | Study on Management Enhancement of CUPS of EPC Nodes |  | 269d? | 2016-12-01 A | 2017-12-12 A | 100% |  |  |  | finish no earlier than 2017-12-12 | S5 | 2152h | 2152h | FS_MECUPS | 38 | Huawei; Jiang, Junyi | Rel-15 | 74 | 32.867 | jiangjunyi@huawei.com |  |  |  |  |
| 3099 | 1277 | Study on Technical Requirements for a new secure platform for 3GPP applications |  | 328d? | 2016-06-13 A | 2017-09-12 A | 100% |  |  |  | finish no earlier than 2017-09-12 | C6 | 2624h | 2624h | FS_NG_SP | 37 | Heiko Kruse | Rel-15 | 72 | 31.801 | heiko.kruse@safrangroup.com |  |  |  |  |
| 3100 | 1278 | Study on technical requirements for a new secure platform for 3GPP applications |  | 140d? | 2017-03-03 A | 2017-09-14 A | 100% |  |  |  | finish no earlier than 2017-09-14 | C6 | 1120h | 1120h | FS_NG_SP2 | 38 | Heiko Kruse | Rel-15 | 75 | 31.801 | heiko.kruse@safrangroup.com |  |  |  |  |
| 3101 | 1279 | Study on scheduling enhancements with CA for UMTS |  | 67d? | 2017-03-15 A | 2017-06-15 A | 100% |  |  |  | finish no earlier than 2017-06-15 | R1 | 536h | 536h | FS_UTRA_CA_sched_enh | 38 | Huawei | Rel-15 | 75 | 25.708 |  |  |  |  |  |
| 3102 | 1280 | Study on Architecture Evolution for E-UTRAN |  | 262d? | 2017-03-15 A | 2018-03-15 A | 100% |  |  |  | finish no earlier than 2018-03-15 | R3 | 2096h | 2096h | FS_LTE_arch_evo | 38 | China Unicom | Rel-15 | 75 | 36.756; 37.876 |  |  |  |  |  |
| 3103 | 1281 | Study on Enhanced Acoustic Test Specifications |  | 1246d? | 2013-03-18 A | 2017-12-12 A | 100% | 2013-03-06 | 2014-09-17 | 401d? | finish no earlier than 2017-12-12 | S4 | 9968h | 9968h | FS_SEATS | 30 | Knowles, Intel | Rel-15 | 59 | 26.931 | Scott Isabelle (Knowles), David Isherwood (Intel) |  |  | Paolo | FS_SEATS |
| 3104 | 1282 | Study on User Services Enhancements in 3GPP for TV Services |  | 328d? | 2016-06-13 A | 2017-09-12 A | 100% |  |  |  | finish no earlier than 2017-09-12 | S4 | 2624h | 2624h | FS_USE_3GPP_4_TV | 37 | Thomas Stockhammer, Qualcomm Incorporated | Rel-15 | 72 | 26.9xx; 26.917 | tsto@qti.qualcomm.com |  |  |  |  |
| 3105 | 1283 | Study on OAM support for assessment of energy efficiency in mobile access networks |  | 421d? | 2015-11-02 A | 2017-06-09 A | 100% |  |  |  | finish no earlier than 2017-06-09 | S5 | 3368h | 3368h | FS_OAM_EE | 36 | Cornily,Jean-Michel, ORANGE | Rel-15 | 70 | 32.856 | jeanmichel.cornily@orange.com |  |  |  |  |
| 3106 | 1284 | Study on Management aspects of selected IoT-related features |  | 322d? | 2016-09-19 A | 2017-12-12 A | 100% |  |  |  | finish no earlier than 2017-12-12 | S5 | 2576h | 2576h | FS_OAM_IOT | 37 | Cisco Systems / Yanover, Vladimir | Rel-15 | 73 | 32.857 |  |  |  |  |  |
| 3107 | 1285 | Study on OAM aspects of SON for AAS-based deployments |  | 421d? | 2015-11-02 A | 2017-06-09 A | 100% |  |  |  | finish no earlier than 2017-06-09 | S5 | 3368h | 3368h | FS_OAM_SON_AAS | 36 | Nokia Networks (Yizhi Yao) | Rel-15 | 70 | (new) | Yizhi.yao@nokia.com |  |  |  |  |
| 3108 | 1286 | Study on OAM aspects of LTE and WLAN integration |  | 204d? | 2017-06-05 A | 2018-03-15 A | 100% |  |  |  | finish no earlier than 2018-03-15 | S5 | 1632h | 1632h | FS_OAM_LWI | 39 | Yizhi Yao, Intel Corporation | Rel-15 | 76 | new; 32.868 | yizhi.yao@intel.com |  |  |  |  |
| 3109 | 1287 | Study on Overload Control for Diameter Charging Applications |  | 653d? | 2015-06-18 A | 2017-12-15 A | 100% |  |  |  | finish no earlier than 2017-12-15 | S5 | 5224h | 5224h | FS_DOCME_CH | 35 | GUO Wenjie, ZTE | Rel-15 | 68 | New 32.869 | guo.wenjie1@zte.com.cn |  |  |  |  |
| 3110 | 1288 | Study on forward compatibility for 3GPP Diameter Charging Applications |  | 194d? | 2016-09-19 A | 2017-06-15 A | 100% |  |  |  | finish no earlier than 2017-06-15 | S5 | 1552h | 1552h | FS_FWDCA | 37 | Nokia, Maryse <dot> Gardella <at> Nokia <dot> com | Rel-15 | 73 | 32.870 | Nokia, Maryse <dot> Gardella <at> Nokia <dot> com |  |  |  |  |
| 3111 | 1289 | Study on Implementation for the Partitioning of Itf-N |  | 534d? | 2016-03-01 A | 2018-03-15 A | 100% |  |  |  | finish no earlier than 2018-03-15 | S5 | 4272h | 4272h | FS_IMP_ITFN | 36 | Hu, Yaxi, China Mobile | Rel-15 | 71 | New 32.880 | huyaxi@cmdi.chinamobile.com |  |  |  |  |
| 3112 | 1290 | Study on Management Aspects of Next Generation Network architecture and features |  | 393d? | 2016-06-13 A | 2017-12-12 A | 100% |  |  |  | finish no earlier than 2017-12-12 | S5 | 3144h | 3144h | FS_MAN_NGNAF | 37 | Nokia Networks, Yizhi Yao | Rel-15 | 72 | (new); 28.802 | Yizhi.yao@nokia.com |  |  |  |  |
| 3113 | 1291 | Study on Management and Orchestration Architecture of Next Generation Network and Service |  | 393d? | 2016-06-13 A | 2017-12-12 A | 100% |  |  |  | finish no earlier than 2017-12-12 | S5 | 3144h | 3144h | FS_NGNS_MOA | 37 | Huawei Technologies, Zou Lan | Rel-15 | 72 | xy.abc; 28.800 | zoulan@huawei.com |  |  |  |  |
| 3114 | 1292 | Study on SON for eCoMP for LTE |  | 263d? | 2016-06-15 A | 2017-06-15 A | 100% |  |  |  | finish no earlier than 2017-06-15 | R3 | 2104h | 2104h | FS_LTE_SON_eCOMP | 37 | Nokia | Rel-15 | 72 |  |  |  |  |  |  |
| 3115 | 1293 | Stopped - Study on IMS Enhanced Spoofed Call Prevention and Detection |  | 849d? | 2014-09-19 A | 2017-12-15 A | 100% |  |  |  | finish no earlier than 2017-12-15 | S3 | 6792h | 6792h | FS_ESCAPADES | 33 | Sprint | Rel-15 | 64 | 33.832 | Gregory.schumacher@sprint.com | 80 |  |  | FS_ESCAPADES |
| 3116 | 1294 | Study on Volume Based Charging Aspects for VoLTE |  | 269d? | 2017-06-05 A | 2018-06-14 A | 100% |  |  |  | start no earlier than 2017-06-05 | S5 | 2152h | 2152h | FS_VBCLTE | 39 | Chen, Ai, China Mobile | Rel-15 | 76 | new; 32.848 | chenai@chinamobile.com |  |  |  |  |
| 3117 | 1295 | STOPPED - Study on UE characteristics and performance for Video |  | 339d? | 2016-03-01 A | 2017-06-15 A | 100% |  |  |  | finish no earlier than 2017-06-15 | S4 | 2712h | 2712h | FS_UE_VTPerf | 36 | Stéphane PROUST, Orange | Rel-15 | 71 | 26.932 | stephane.proust@orange.com | 80 |  |  |  |
| 3118 | 1296 | Study on UE Application Layer Data Throughput Performance Expansion for CA |  | 131d? | 2017-12-15 A | 2018-06-15 A | 100% |  |  |  | finish no earlier than 2018-06-15 | R5 | 1048h | 1048h | FS_UE_App_Data_Perf_CA | 40 | PCTEST Engineering Lab | Rel-15 | 78 |  |  |  |  |  |  |
| 3119 | 1297 | Study on system and functional aspects of Energy Efficiency in 5G networks |  | 400d? | 2017-06-05 A | 2018-12-14 A | 100% |  |  |  | finish no earlier than 2018-12-14 | S5 | 3200h | 3200h | FS_EE_5G | 39 | CORNILY, Jean-Michel, ORANGE | Rel-15 | 76 | new; 32.872; 32.972 | jeanmichel.cornily@orange.com |  |  |  |  |
| 3120 | 1298 | --- RELEASE 14 --- | milestone | 0d? | 2014-12-12 A | 2014-12-12 A | 100% |  |  |  | finish no earlier than 2014-12-12 |  |  |  |  |  |  | Rel-14 |  |  |  |  |  |  |  |
| 3121 | 1299 | Release 14 on Mission Critical | milestone | 0d? | 2016-06-09 A | 2016-06-09 A | 100% |  |  |  | finish no earlier than 2016-06-09 |  |  |  |  |  |  | Rel-14 |  |  |  |  |  |  |  |

Notes:
- 3073: basket CA WI¦no Perf. part
- 3074: basket CA WI¦no Perf. part¦27/6/18: Compl:0%->100%¦…
- 3075: Perf. Part was introduced and completed at RAN #80
- 3076: to add Power Class 1 (+31dBm) for UE operating in Europe @ 450MHz in frequency bands that are suitable for BB-PPDR operation, i.e. band 31 and band 72;
- 3077: to add Power Class 1 (+31dBm) for UE operating in Europe @ 450MHz in frequency bands that are suitable for BB-PPDR operation, i.e. band 31 and band 72;27/6/18: moved from Rel-16
- 3078: 16/1/19: 0%->100
- 3079: -
- 3080: -
- 3081: 6/10/16: Acronym FS_MA_RVNF ->FS_MA_RNVNF ¦6/10/16: 32.864 added¦1/12/16: 0%->5¦6/3/17: 5%->10¦7/6/17: 10%->40¦11/9/17: 40%->70¦15/12/17: 70%->100¦15/12/17: FCD:09/17->12/17
- 3082: CU = central unit, DU = distributed unit¦results will be captured in existing TR 38.801¦19/9/17: Compl:0%->30%¦19/9/17: WID: RP-170818->RP-171717¦15/12/17: 38.816 added;¦8/1/18: Compl:30%->95%¦8/1/18: CD:Fr ¦27/6/18
- 3083: TR 38.8XX19/6/17: Compl:0%->25%19/6/17: CD:Fri 15/12/17->Thu 15/03/1819/6/17: WID: RP-170717->RP-171450¦30/6/17: 38.811 added;¦19/9/17: Compl:25%->40%¦8/1/18: CD:Thu 15/03/18->Fri 15/06/18¦27/3/18: Compl:40%->45%¦27/6/18: Compl:4
- 3084: 19/9/16: 0%->25¦22/9/16: WID:SP-160227->SP-160727¦22/9/16: FCD:12/16->03/17¦1/12/16: 25%->45¦6/3/17: 45%->60¦7/6/17: FCD:03/17->12/17 so Rel-14->Rel-15¦7/6/17: 60%->65¦11/9/17: 65%->100
- 3085: 19/9/17: Compl:0%->45%19/9/17: WID: RP-171421->RP-171905¦15/12/17: 38.806 added;¦8/1/18: Compl:45%->100%
- 3086: -
- 3087: 1/7/16: Compl:0%->50%¦28/7/16: 36.740 added¦26/9/16: WID: RP-161328->RP-161670¦20/12/16: CD:Thu 15/0;21/3/17: CD:Fri 15 12/7/17: 50%->100 since declared as stopped
- 3088: 6/10/16: 36.766 added¦20/12/16: Compl:0%->35% 21/3/17: Compl:35%->65%¦19/6/17: Compl:65%->100%
- 3089: ¦21/3/17: WID: RP-162541->RP-170403¦21/3/17: 36.754 added;19/6/17: Compl:0%->90%¦19/9/17: Compl:90%->100
- 3090: 12/7/17: 36.757 added;¦19/9/17: Compl:0%->35%¦ 8/1/18: Compl:35%->100%
- 3091: -
- 3092: 15/12/17: 26.973 added;¦15/12/17: 0%->80¦16/3/18: 80%->100
- 3093: 1/7/16: Compl:0%->2%;26/9/16: Compl:2%->5%¦6/10/16: 36.746 added¦20/12/16: Compl:5%->15%;21/3/17: Compl:15%->35%…19/6/17: ;
- 3094: 28/7/16: 21.866 added;¦9/6/17: FCD:12/16->9/6/17 (Rel-14->Rel-15)¦0%->100
- 3095: TR 38.8XX19/6/17: WID: RP-170837->RP-171093¦12/7/17: 37.885 added;19/9/17: Compl:0%->5%¦8/1/18: Compl:5%->10%¦8/1/18: CD:Fri 15/12/17->Thu 15/03/18¦27/3/18: Compl:10%->30%¦27/3/18: CD:Thu 15/03/18->Fri 15/06/18¦27
- 3096: 11/9/17: 0%->15¦15/12/17: 15%->60¦15/12/17: FCD:12/17->03/18¦16/3/18: 60%->100
- 3097: 9/6/16: 0%->6¦28/7/16: 23.798 added¦1/12/16: FCD:09/16->12/16¦1/12/16: 6%->15. 7/12/16: Moved from Rel-14 according to SP-160806.¦6/3/17: 15%->50¦7/6/17: 50%->100
- 3098: 6/3/17: 0%->5¦7/6/17: 5%->40¦7/6/17: FCD:09/17->12/17¦11/9/17: 40%->50¦15/12/17: 50%->100
- 3099: 16/9/16: 0%->15. ¦5/6/17: 15%->70. 5/6/17: moved to Rel-15 (talks with P. Jolivet)¦5/6/17: FCD:12/16->09/20¦15/12/17: 70%->100
- 3100: 21/3/17: 31.801 added;¦11/9/17: 0%->70¦15/12/17: 70%->100
- 3101: TR 25.7XX¦19/6/17: Compl:0%->100%¦ 12/7/17: 25.708 added;
- 3102: TR 36.8XX¦12/7/17: 36.756 added;19/9/17: Compl:0%->40%¦15/12/17: 37.876 added;¦8/1/18: Compl:40%->827/3/18: Compl:85%->100%
- 3103: SP#65 completion 09/14=>12/14. Moved to Rel-13. Dec.14: 30->35%, CD 12/14->03/15. Mar.15: CD: 06/16. 40%¦June2015: Compl:40%->45. . 15/4/16: moved from R 21/3/17: Moved from Rel-14 (not completed on time)¦7/6/17: FCD:06/17->12/17¦11/9/17: 80%->8
- 3104: 19/9/16: 0%->30¦6/10/16: 26.917 added¦1/12/16: 30%->60¦1/12/16: FCD:12/16->03/17¦6/3/17: 60%->75¦6/3/17: FCD:03/17->06/17¦21/3/17: Moved from Rel-14 (not completed on time)¦7/6/17: 75%->80¦7/6/17: FCD:06/17->09/17¦11/9/17: 80%->100
- 3105: 13/6/16: WID:SP-150674->SP-160430¦13/6/16: 0%->55¦1/12/16: 55%->80¦6/3/17: FCD:03/17->06/17¦6/3/17: 80%->90¦21/3/17: moved from rel-14¦7/6/17: 90%->100
- 3106: 6/10/16: 32.857 added¦1/12/16: 0%->5¦21/3/17: moved from Rel-14¦7/6/17: FCD:06/17->12/17¦7/6/17: 5%->20¦11/9/17: 20%->30¦15/12/17: 30%->45¦16/3/18: 45%->100
- 3107: 13/6/16: 0%->40¦19/9/16: FCD:09/16->12/16¦19/9/16: 40%->60¦1/12/16: FCD:12/16->03/17¦1/12/16: 60%->70¦6/3/17: FCD:03/17->06/17¦21/3/17: moved from rel-14¦7/6/17: 70%->100
- 3108: 30/6/17: 32.868 added;¦11/9/17: 0%->10¦15/12/17: 10%->50¦16/3/18: 50%->90¦7/6/18: 90%->100
- 3109: Aug2015: moved to Rel-14 (email CT and EG)¦07/09/15: 0%->5¦7/3/16: 5%->10¦13/6/16: FCD:03/16->09/16¦19/9/16: FCD: 09/16->06/17¦6/3/17: FCD:03/17->12/17¦21/3/17: moved from rel-14¦7/6/17: 10%->25¦8/6/17: WID:SP-150310->SP-170481¦11/9/17: 25%->3
- 3110: 6/10/16: 32.870 added¦1/12/16: 0%->10¦21/3/17: moved from rel-14¦11/9/17: 10%->40¦15/12/17: 40%->100
- 3111: 13/6/16: 0%->10¦19/9/16: 10%->35¦1/12/16: 35%->40¦6/3/17: FCD:03/17->03/18¦21/3/17: moved from rel-14¦7/6/17: 40%->60¦11/9/17: 60%->80¦15/12/17: 80%->100
- 3112: 28/7/16: 28.802 added¦19/9/16: 0%->5¦1/12/16: 5%->10¦6/3/17: FCD:03/17->06/17¦6/3/17: 10%->40¦21/3/17: moved from rel-14¦7/6/17: FCD:06/17->12/17¦7/6/17: 40%->60¦11/9/17: 60%->70¦15/12/17: 70%->100
- 3113: 28/7/16: 28.800 added¦19/9/16: 0%->10¦6/3/17: FCD:03/17->06/17¦21/3/17: moved from rel-14¦7/6/17: FCD:06/17->12/17¦7/6/17: 10%->25¦11/9/17: 25%->30¦15/12/17: 30%->100
- 3114: 26/9/16: Compl:0%->10%. ¦20/12/16: Compl:10%->40%21/3/17: Compl:40%->60%¦19/6/17: Compl:60%->100%
- 3115: Dec.14: TR number added. 3/3/15: 0->5%¦June2015: Compl:5%->25¦9/12/15: 25%->30¦21/3/17: moved from Rel-13¦21/3/17: FCD:09/15->12/17¦7/6/17: Stopped (30%->100%)
- 3116: 30/6/17: 32.848 added;¦11/9/17: 0%->5¦15/12/17: 5%->35¦16/3/18: 35%->45¦7/6/18: 45%->100
- 3117: 11/6/16: 0%->10¦19/9/16: 10%->30, FCD: 12/16->06/17¦21/3/17: Moved from Rel-14 (not completed on time)¦7/6/17: Stopped, so 30%->100
- 3118: compare REL-11 SI FS_UE_App_Data_Perf¦note: SI FS_UE_App_Data_Perf_CA is addressing 2DL/1UL involving also an unlicensed carrier of REL-13 LTE_LAA¦instead of a new TR, the TR 37.901 will be updated for REL-15¦ ;
- 3119: 30/6/17: 32.872 added;¦11/9/17: 0%->5¦15/12/17: 32.972 added;¦15/12/17: 5%->40¦16/3/18: 40%->60¦7/6/18: 60%->65¦7/6/18: FCD:06/18->12/18¦10/9/18: 65%->85¦7/12/18: 85%->100
- 3120: -
- 3121: -

| ID | WBS | Task | Duration | Start | Finish | Complete | Constraint | Resources | Work | Actual work | Acronym | PCG approved | Release | TSG approved | Impacted TSs and TRs | WI rapporteur name | WI rapporteur e-mail | Status Report |
| --- | --- | --- | --- | --- | --- | --- | --- | --- | --- | --- | --- | --- | --- | --- | --- | --- | --- | --- |
| 3122 | 1300 | **Mission Critical Improvements** | 1220d? | 2015-04-14 A | 2019-12-13 A | 100% |  |  | 30800h | 30800h | MCImp | 36 | Rel-14 | 70 |  |  |  |  |
| 3123 | 1300.1 | Mission Critical Push to Talk over LTE Realignment | 138d? | 2015-12-07 A | 2016-06-15 A | 100% | finish no earlier than 2016-06-15 | S1 | 1104h | 1104h | MCImp-MCPTTR | 36 | Rel-14 | 70 | 22.179 | Andrew Thiessen | andrew (at) its (dot) bldrdoc (dot) gov | SP-170406 |
| 3124 | 1300.2 | **Enhancements for Mission Critical Push To Talk** | 264d? | 2016-06-13 A | 2017-06-14 A | 100% |  |  | 5624h | 5624h | MCImp-eMCPTT | 37 | Rel-14 | 72 | 23.379; 23.280; 23.281; 23.282; 23.379 | Lazara, Dom | dom.lazara@motorolasolutions.com |  |
| 3125 | 1300.2.1 | Stage 2 of Enhancements for Mission Critical Push To Talk | 135d? | 2016-06-13 A | 2016-12-15 A | 100% | finish no earlier than 2016-12-15 | S6 | 1080h | 1080h | MCImp-eMCPTT | 37 | Rel-14 | 72 | 23.379; 23.280; 23.281; 23.282; 23.379 | Lazara, Dom | dom.lazara@motorolasolutions.com |  |
| 3126 | 1300.2.2 | **Stage 3 of Enhancements for Mission Critical Push To Talk** | 140d? | 2016-12-01 A | 2017-06-14 A | 100% |  | ct | 4544h | 4544h | MCImp-eMCPTT-CT | 38 | Rel-14 | 74 |  | FREDERICKS, Bob | bobfredericks@motorolasolutions.com |  |
| 3127 | 1300.2.2.1 | CT1 aspects of Enhancements for Mission Critical Push To Talk | 140d? | 2016-12-01 A | 2017-06-14 A | 100% | finish no earlier than 2017-06-14 | C1 | 1120h | 1120h | MCImp-eMCPTT-CT | 38 | Rel-14 | 74 | 24.379; 24.380; 24.381; 24.382; 24.383; 24.384 | FREDERICKS, Bob | bobfredericks@motorolasolutions.com |  |
| 3128 | 1300.2.2.2 | CT3 aspects of Enhancements for Mission Critical Push To Talk | 74d? | 2016-12-01 A | 2017-03-14 A | 100% | finish no earlier than 2017-03-14 | C3 | 592h | 592h | MCImp-eMCPTT-CT | 38 | Rel-14 | 74 | 29.165; 29.213; 29.214 | FREDERICKS, Bob | bobfredericks@motorolasolutions.com |  |
| 3129 | 1300.2.2.3 | CT4 aspects of Enhancements for Mission Critical Push To Talk | 74d? | 2016-12-01 A | 2017-03-14 A | 100% | finish no earlier than 2017-03-14 | C4 | 592h | 592h | MCImp-eMCPTT-CT | 38 | Rel-14 | 74 | 23.003; 29.228; 23.335; 29.283 | FREDERICKS, Bob | bobfredericks@motorolasolutions.com |  |
| 3130 | 1300.2.2.4 | CT6 aspects of Enhancements for Mission Critical Push To Talk | 140d? | 2016-12-01 A | 2017-06-14 A | 100% | finish no earlier than 2017-06-14 | C6 | 1120h | 1120h | MCImp-eMCPTT-CT | 38 | Rel-14 | 74 | 31.102; 31.103 | FREDERICKS, Bob | bobfredericks@motorolasolutions.com |  |
| 3131 | 1300.3 | Mission Critical Services Common Requirements | 138d? | 2015-12-07 A | 2016-06-15 A | 100% | finish no earlier than 2016-06-15 | S1 | 1104h | 1104h | MCImp-MCCoRe | 36 | Rel-14 | 70 | New 22.280 | Andrew Thiessen | andrew (at) its (dot) bldrdoc (dot) gov | SP-170407 |
| 3132 | 1300.4 | Common functional architecture to support mission critical services | 135d? | 2016-06-13 A | 2016-12-15 A | 100% | finish no earlier than 2016-12-15 | S6 | 1080h | 1080h | MCImp-MC_ARCH | 37 | Rel-14 | 72 | 23.280; 23.379; 23.281; 23.282; 23.280 | Niranth Amogh, Huawei Telecommunications India | namogh@huawei.com |  |
| 3133 | 1300.5 | **Mission Critical Video over LTE** | 568d? | 2015-04-14 A | 2017-06-14 A | 100% |  |  | 8528h | 8528h | MCImp-MCVideo | 36 | Rel-14 | 70 |  | Emmanuelle Villebrun | Emmanuelle.villebrun@gendarmerie.interieur.gouv.fr |  |
| 3134 | 1300.5.1 | Study on Mission Critical Video over LTE | 176d? | 2015-04-14 A | 2015-12-15 A | 100% | finish no earlier than 2015-12-15 | S1 | 1408h | 1408h | FS_MCVideo | 34 | Rel-14 | 67 | New 22.879 | Villebrun, Emmanuelle (French MoI) | emmanuelle.villebrun@gendarmerie.interieur.gouv.fr |  |
| 3135 | 1300.5.2 | Stage 1 of MCVideo | 138d? | 2015-12-07 A | 2016-06-15 A | 100% | finish no earlier than 2016-06-15 | S1 | 1104h | 1104h | MCImp-MCVideo | 36 | Rel-14 | 70 | New 22.281 | Emmanuelle Villebrun | Emmanuelle.villebrun@gendarmerie.interieur.gouv.fr |  |
| 3136 | 1300.5.3 | Stage 2 for MCVideo | 135d? | 2016-06-13 A | 2016-12-15 A | 100% | finish no earlier than 2016-12-15 | S6 | 1080h | 1080h | MCImp-MCVideo | 37 | Rel-14 | 72 | 23.281; 23.280; 23.379; 23.282; 23.281 | Niranth Amogh, Huawei Telecommunications India | namogh@huawei.com |  |
| 3137 | 1300.5.4 | MCVideo codecs and media handling | 47d? | 2017-01-11 A | 2017-03-16 A | 100% | finish no earlier than 2017-03-16 | S4 | 376h | 376h | MCImp-MCVideo | 38 | Rel-14 | 75 | 26.281 | John Lambrou (Motorola Solutions) | john (dot) lambrou (at) motorolasolutions (dot) com |  |
| 3138 | 1300.5.5 | **Stage 3 of MCVideo** | 140d? | 2016-12-01 A | 2017-06-14 A | 100% |  | ct | 4560h | 4560h | MCImp-MCVIDEO-CT | 38 | Rel-14 | 74 | 24.581; 24.281 | PATEL, Milan | milan.patel@huawei.com |  |
| 3139 | 1300.5.5.1 | CT1 aspects 3 of MCVideo | 140d? | 2016-12-01 A | 2017-06-14 A | 100% | finish no earlier than 2017-06-14 | C1 | 1120h | 1120h | MCImp-MCVIDEO-CT | 38 | Rel-14 | 74 | 24.381; 24.382; 24.383; 24.384 | PATEL, Milan | milan.patel@huawei.com |  |
| 3140 | 1300.5.5.2 | CT3 aspects 3 of MCVideo | 75d? | 2016-12-01 A | 2017-03-15 A | 100% | finish no earlier than 2017-03-15 | C3 | 600h | 600h | MCImp-MCVIDEO-CT | 38 | Rel-14 | 74 | 29.165; 29.213; 29.214 | PATEL, Milan | milan.patel@huawei.com |  |
| 3141 | 1300.5.5.3 | CT4 aspects 3 of MCVideo | 75d? | 2016-12-01 A | 2017-03-15 A | 100% | finish no earlier than 2017-03-15 | C4 | 600h | 600h | MCImp-MCVIDEO-CT | 38 | Rel-14 | 74 | 23.003; 23.335; 29.283 | PATEL, Milan | milan.patel@huawei.com |  |
| 3142 | 1300.5.5.4 | CT6 aspects 3 of MCVideo | 140d? | 2016-12-01 A | 2017-06-14 A | 100% | finish no earlier than 2017-06-14 | C6 | 1120h | 1120h | MCImp-MCVIDEO-CT | 38 | Rel-14 | 74 | 31.102; 31.103 | PATEL, Milan | milan.patel@huawei.com |  |
| 3143 | 1300.6 | **Mission Critical Data over LTE** | 568d? | 2015-04-14 A | 2017-06-14 A | 100% |  |  | 8152h | 8152h | MCImp-MCData | 36 | Rel-14 | 70 |  | Emmanuelle Villebrun | Emmanuelle.villebrun@gendarmerie.interieur.gouv.fr |  |
| 3144 | 1300.6.1 | Study on Mission Critical Data Communications | 176d? | 2015-04-14 A | 2015-12-15 A | 100% | finish no earlier than 2015-12-15 | S1 | 1408h | 1408h | FS_MCDATA | 34 | Rel-14 | 67 | New 22.880 | Villebrun, Emmanuelle (French MoI) | emmanuelle.villebrun@gendarmerie.interieur.gouv.fr |  |
| 3145 | 1300.6.2 | Stage 1 of MCData | 138d? | 2015-12-07 A | 2016-06-15 A | 100% | finish no earlier than 2016-06-15 | S1 | 1104h | 1104h | MCImp-MCData | 36 | Rel-14 | 70 | New 22.282 | Emmanuelle Villebrun | Emmanuelle.villebrun@gendarmerie.interieur.gouv.fr |  |
| 3146 | 1300.6.3 | Stage 2 for MCData | 135d? | 2016-06-13 A | 2016-12-15 A | 100% | start no earlier than 2016-06-13 | S6 | 1080h | 1080h | MCImp-MCData | 37 | Rel-14 | 72 | 23.282 | David Freeman (UK Home Office) | david@dnf-consulting.co.uk |  |

Notes:
- 3122: Umbrella Feature
- 3123: 2/3/16: FCD: 03/16->06/16. ES in SP-160102¦0->75%¦9/6/16: 75%->100
- 3124: 28/7/16: 23.379 added¦19/9/16: 0%->35¦1/12/16: 35%->100
- 3125: 28/7/16: 23.379 added¦19/9/16: 0%->35¦1/12/16: 35%->100
- 3127: 6/3/17: 0%->20¦5/6/17: 20%->95¦14/9/17: 95%->97¦15/12/17: 97%->100
- 3128: 5/6/17: 0%->100
- 3129: 6/3/17: 0%->100
- 3130: 5/6/17: 0%->100. No work identified for CT6.
- 3131: 2/3/16: FCD: 03/16->06/16. ES in SP-160104¦0->75%¦9/6/16: 75%->100
- 3132: 28/7/16: 23.280 added¦19/9/16: 0%->40¦1/12/16: 40%->95¦3/3/17: 95%->100
- 3133: 2/3/16: FCD: 03/16->06/16. ES in SP-160106¦0->80%¦9/6/16: 80%->100
- 3134: 1/4/15:TR number added¦June2015: Compl:0%->50¦07/09/15: 50%->70¦7/12/15: 70%->100
- 3135: 2/3/16: FCD: 03/16->06/16. ES in SP-160106¦0->80%¦9/6/16: 80%->100
- 3136: 28/7/16: 23.281 added¦19/9/16: 0%->25¦1/12/16: 25%->95¦3/3/17: 95%->100
- 3137: 6/3/17: 0%->100
- 3139: 6/3/17: 0%->25¦5/6/17: 25%->90¦14/9/17: 90%->100
- 3140: 5/6/17: 0%->100
- 3141: 6/3/17: 0%->100
- 3142: 5/6/17: 0%->100. No work identified for CT6.
- 3143: 2/3/16: FCD: 03/16->06/16. ES in SP-160109¦0->80%¦9/6/16: 80%->100
- 3144: 1/4/15:TR number added¦June2015: Compl:0%->20¦07/09/15: 20%->90¦7/12/15: 90%->100
- 3145: 2/3/16: FCD: 03/16->06/16. ES in SP-160109¦0->80%¦9/6/16: 80%->100
- 3146: 28/7/16: 23.282 added¦19/9/16: 0%->10¦1/12/16: 10%->95¦3/3/17: 95%->100

| ID | WBS | Task | Type | Duration | Start | Finish | Complete | Constraint | Resources | Work | Actual work | Acronym | PCG approved | WI rapporteur name | WI rapporteur e-mail | Release | TSG approved | Status Report |
| --- | --- | --- | --- | --- | --- | --- | --- | --- | --- | --- | --- | --- | --- | --- | --- | --- | --- | --- |
| 3147 | 1300.6.4 | **Stage 3 of MCData** |  | 140d? | 2016-12-01 A | 2017-06-14 A | 100% |  | ct | 4560h | 4560h | MCImp-MCDATA-CT | 38 | HASON, Baruh | baruh.hason@motorolasolutions.com | Rel-14 | 74 |  |
| 3148 | 1300.6.4.1 | CT1 aspects of MCData |  | 140d? | 2016-12-01 A | 2017-06-14 A | 100% | finish no earlier than 2017-06-14 | C1 | 1120h | 1120h | MCImp-MCDATA-CT | 38 | HASON, Baruh | baruh.hason@motorolasolutions.com | Rel-14 | 74 |  |
| 3149 | 1300.6.4.2 | CT3 aspects of MCData |  | 75d? | 2016-12-01 A | 2017-03-15 A | 100% | finish no earlier than 2017-03-15 | C3 | 600h | 600h | MCImp-MCDATA-CT | 38 | HASON, Baruh | baruh.hason@motorolasolutions.com | Rel-14 | 74 |  |
| 3150 | 1300.6.4.3 | CT4 aspects of MCData |  | 75d? | 2016-12-01 A | 2017-03-15 A | 100% | finish no earlier than 2017-03-15 | C4 | 600h | 600h | MCImp-MCDATA-CT | 38 | HASON, Baruh | baruh.hason@motorolasolutions.com | Rel-14 | 74 |  |
| 3151 | 1300.6.4.4 | CT6 aspects of MCData |  | 140d? | 2016-12-01 A | 2017-06-14 A | 100% | finish no earlier than 2017-06-14 | C6 | 1120h | 1120h | MCImp-MCDATA-CT | 38 | HASON, Baruh | baruh.hason@motorolasolutions.com | Rel-14 | 74 |  |
| 3152 | 1300.7 | Security of the Mission Critical Service |  | 194d? | 2016-09-19 A | 2017-06-15 A | 100% | finish no earlier than 2017-06-15 | S3 | 1552h | 1552h | MCSec | 37 | Haigh, Peter, CESG | peter.haigh@cesg.gsi.gov.uk | Rel-14 | 73 |  |
| 3153 | 1300.8 | UE Conformance Test Aspects - Mission Critical Improvements |  | 457d? | 2018-03-15 A | 2019-12-13 A | 100% | finish no earlier than 2019-12-15 | R5 | 3656h | 3656h | MCImp-UEConTest | 40 | NIST |  | Rel-14 | 79 |  |
| 3154 | 1301 | **Protocol enhancements for MCPTT over LTE** |  | 129d? | 2016-09-16 A | 2017-03-15 A | 100% |  | ct | 5160h | 5160h | MCPTTProtoc1 | 37 | Ricky Kaura | ricky.kaura@samsung.com | Rel-14 | 73 |  |
| 3155 | 1301.1 | CT1 aspects of MCPTTProtoc1 |  | 129d? | 2016-09-16 A | 2017-03-15 A | 100% | finish no earlier than 2017-03-15 | C1 | 1032h | 1032h | MCPTTProtoc1 | 37 | Ricky Kaura | ricky.kaura@samsung.com | Rel-14 | 73 |  |
| 3156 | 1301.2 | CT3 aspects of MCPTTProtoc1 |  | 129d? | 2016-09-16 A | 2017-03-15 A | 100% | finish no earlier than 2017-03-15 | C3 | 1032h | 1032h | MCPTTProtoc1 | 37 | Ricky Kaura | ricky.kaura@samsung.com | Rel-14 | 73 |  |
| 3157 | 1301.3 | CT4 aspects of MCPTTProtoc1 |  | 129d? | 2016-09-16 A | 2017-03-15 A | 100% | finish no earlier than 2017-03-15 | C4 | 1032h | 1032h | MCPTTProtoc1 | 37 | Ricky Kaura | ricky.kaura@samsung.com | Rel-14 | 73 |  |
| 3158 | 1301.4 | CT6 aspects of MCPTTProtoc1 |  | 129d? | 2016-09-16 A | 2017-03-15 A | 100% | finish no earlier than 2017-03-15 | C6 | 1032h | 1032h | MCPTTProtoc1 | 37 | Ricky Kaura | ricky.kaura@samsung.com | Rel-14 | 73 |  |
| 3159 | 1302 | Release 14 on V2X | milestone | 0d? | 2016-06-09 A | 2016-06-09 A | 100% | finish no earlier than 2016-06-09 |  |  |  |  |  |  |  | Rel-14 |  |  |
| 3160 | 1303 | **LTE support for V2X services** |  | 1006d? | 2015-02-09 A | 2018-12-14 A | 100% |  |  | 21216h | 21216h | V2XLTE | 35 |  |  | Rel-14 | 68 |  |
| 3161 | 1303.1 | Stage 1 for LTE support for V2X services |  | 137d? | 2015-09-09 A | 2016-03-17 A | 100% | finish no earlier than 2016-03-17 | S1 | 1096h | 1096h | V2XLTE | 35 |  |  | Rel-14 | 68 |  |
| 3162 | 1303.2 | Architecture enhancements for LTE support of V2X services |  | 137d? | 2016-06-09 A | 2016-12-15 A | 100% | finish no earlier than 2016-12-15 | S2 | 1096h | 1096h | V2XARC | 37 | LG Electronics, LaeYoung Kim | laeyoung.kim@lge.com | Rel-14 | 72 |  |
| 3163 | 1303.3 | Security aspect of LTE support of V2X services |  | 141d? | 2016-12-01 A | 2017-06-15 A | 100% | finish no earlier than 2017-06-15 | S3 | 1128h | 1128h | V2XLTE-Sec | 38 | Huawei, Marcus Wong | mwong@huawei.com | Rel-14 | 74 |  |
| 3164 | 1303.4 | **RAN aspects of LTE-based V2X Services** |  | 654d? | 2016-06-15 A | 2018-12-14 A | 100% |  |  | 7344h | 7344h | LTE_V2X | 37 | LG Electronics |  | Rel-14 | 72 |  |
| 3165 | 1303.4.1 | Core part: LTE-based V2X Services |  | 197d? | 2016-06-15 A | 2017-03-15 A | 100% | finish no earlier than 2017-03-15 | R1 | 1576h | 1576h | LTE_V2X-Core | 37 | LG Electronics |  | Rel-14 | 72 | RP-170237 |
| 3166 | 1303.4.2 | Perf. part: LTE-based V2X Services |  | 329d? | 2016-06-15 A | 2017-09-15 A | 100% | finish no earlier than 2017-09-15 | R4 | 2632h | 2632h | LTE_V2X-Perf | 37 | LG Electronics |  | Rel-14 | 72 |  |
| 3167 | 1303.4.3 | UE Conformance Test Aspects - Support for LTE-based V2X Services |  | 392d? | 2017-06-15 A | 2018-12-14 A | 100% | finish no earlier than 2018-12-15 | R5 | 3136h | 3136h | LTE_V2X-UEConTest | 39 | Huawei |  | Rel-14 | 76 |  |
| 3168 | 1303.5 | **CT aspects of V2X Services** |  | 129d? | 2016-09-16 A | 2017-03-15 A | 100% |  | ct | 5160h | 5160h | V2X-CT | 37 | Taehun Kim | taehun78.kim@lge.com | Rel-14 | 73 |  |
| 3169 | 1303.5.1 | CT1 aspects of V2X Services |  | 129d? | 2016-09-16 A | 2017-03-15 A | 100% | finish no earlier than 2017-03-15 | C1 | 1032h | 1032h | V2X-CT | 37 | Taehun Kim | taehun78.kim@lge.com | Rel-14 | 73 |  |
| 3170 | 1303.5.2 | CT3 aspects of V2X Services |  | 129d? | 2016-09-16 A | 2017-03-15 A | 100% | finish no earlier than 2017-03-15 | C3 | 1032h | 1032h | V2X-CT | 37 | Taehun Kim | taehun78.kim@lge.com | Rel-14 | 73 |  |
| 3171 | 1303.5.3 | CT4 aspects of V2X Services |  | 129d? | 2016-09-16 A | 2017-03-15 A | 100% | finish no earlier than 2017-03-15 | C4 | 1032h | 1032h | V2X-CT | 37 | Taehun Kim | taehun78.kim@lge.com | Rel-14 | 73 |  |
| 3172 | 1303.5.4 | CT6 aspects of V2X Services |  | 129d? | 2016-09-16 A | 2017-03-15 A | 100% | finish no earlier than 2017-03-15 | C6 | 1032h | 1032h | V2X-CT | 37 | Taehun Kim | taehun78.kim@lge.com | Rel-14 | 73 |  |

Notes:
- 3147: Impacted TSs and TRs: 24.582; 24.282
- 3148: 6/3/17: 0%->10¦5/6/17: 10%->65¦5/6/17: 65%->90¦14/9/17: 90%->96¦15/12/17: 96%->100 / Impacted TSs and TRs: 24.381; 24.382; 24.383; 24.384
- 3149: 5/6/17: 0%->100 / Impacted TSs and TRs: 29.165; 29.213; 29.214
- 3150: 6/3/17: 0%->100 / Impacted TSs and TRs: 23.003; 23.335; 29.283
- 3151: No work identified. / Impacted TSs and TRs: 31.102; 31.103
- 3152: 6/10/16: 33.180 added¦1/12/16: 0%->25¦6/3/17: 25%->60¦7/6/17: 60%->85¦11/9/17: 85%->100 / Impacted TSs and TRs: 33.180
- 3153: tested: REL-14 WI MCImp (SA/CT WI: Mission Critical Improvements)¦to provide conformance test specifications for the Rel-14 core requirements for improvements to Mission Critical Services (MCPTT, MCVideo and MCData).;; 25/9/20: 5%->100
- 3154: This Feature is a stage-3 only feature that fixes/enhances MCPTT protocol level (not visible from stage2). Not to be confused with Rel-14 MCPTT Stage 3.
- 3155: 6/3/17: 5%->100 / Impacted TSs and TRs: 24.229; 24.379; 24.380; 24.381; 24.382; 24.383; 24.384; 24.980
- 3156: 2/12/16: 0%->20¦6/3/17: 20%->100 / Impacted TSs and TRs: 29.165; 29.212; 29.213; 29.214
- 3157: 6/3/17: 0%->100 / Impacted TSs and TRs: 23.003; 23.008; 29.283
- 3158: 5/6/17: 0%->100. No more work identified. / Impacted TSs and TRs: 31.102
- 3159: -
- 3160: 7/12/15: 0%->5¦28/1/16: 22.185 added¦2/3/16: 5%->90¦9/6/16: 90%->100 / Impacted TSs and TRs: 22.278; 22.185
- 3161: 7/12/15: 0%->5¦28/1/16: 22.185 added¦2/3/16: 5%->90¦9/6/16: 90%->100 / Impacted TSs and TRs: 22.278; 22.185
- 3162: 28/7/16: 23.285 added¦19/9/16: 0%->85¦1/12/16: FCD:09/16->12/16¦1/12/16: 85%->100 / Impacted TSs and TRs: 23.285
- 3163: 6/3/17: 0%->75¦7/6/17: 75%->100 / Impacted TSs and TRs: 33.185
- 3164: follow-up WI of REL-14 SI FS_LTE_V2X
- 3165: follow-up WI of REL-14 SI FS_LTE_V2X26/9/16: Compl:0%->15%26/9/16: WID: RP-161298->RP-161894¦6/10/16: 36.786 added¦6/10/16: added¦20/12/16: Compl:15%->75% 21/3/17: Compl:75%->100% / Impacted TSs and TRs: 36.786;
- 3166: ¦26/9/16: WID: RP-161298->RP-161894¦20/12/16: WID: RP-161894->RP-162519¦20/12/16: Stat Rep: ->RP-162519¦19/6/17: Compl:0%->75%¦19/9/17: Compl:75%->100%
- 3167: ¦19/9/17: Compl:0%->20%¦8/1/18: Compl:20%->40%¦ 27/3/18: Compl:40%->55%; 14/1/20: WID:RP-172356->RP-192556; 14/1/20: 65%->100
- 3169: 6/10/16: 24.385 added¦6/10/16: 24.386 added¦2/12/16: 0%->65¦6/3/17: 65%->100 / Impacted TSs and TRs: 23.122; 24.301; 24.334; 24.385; 24.386
- 3170: 6/10/16: 29.387 added¦2/12/16: 0%->40¦6/3/17: 40%->60¦5/6/17: 60%->100 / Impacted TSs and TRs: 29.212; 29.468; 29.387
- 3171: 6/10/16: 29.388 added¦6/10/16: 29.389 added¦2/12/16: 0%->80¦6/3/17: 80%->100 / Impacted TSs and TRs: 23.003; 23.007; 23.008; 29.272; 29.388; 29.389
- 3172: 7/3/17: 0%->100 / Impacted TSs and TRs: 31.102; 31.111

| ID | WBS | Task | Type | Duration | Start | Finish | Complete | Constraint | Resources | Work | Actual work | Acronym | PCG approved | WI rapporteur name | WI rapporteur e-mail | Release | TSG approved | Status Report |
| --- | --- | --- | --- | --- | --- | --- | --- | --- | --- | --- | --- | --- | --- | --- | --- | --- | --- | --- |
| 3173 | 1303.6 | **Study on LTE support for V2X services** |  | 355d? | 2015-02-09 A | 2016-06-17 A | 100% |  |  | 5392h | 5392h | FS_V2XLTE | 34 | Ki-Dong Lee (LG electronics) | kidong.lee@lge.com | Rel-14 | 67 |  |
| 3174 | 1303.6.1 | Study on Stage 1 of LTE support for V2X services |  | 1d? | 2015-02-09 A | 2015-02-09 A | 100% | start no earlier than 2015-09-07 | S1 | 8h | 8h | FS_V2XLTE_S1 | 34 | Ki-Dong Lee (LG electronics) | kidong.lee@lge.com | Rel-14 | 67 |  |
| 3175 | 1303.6.2 | Study on Stage 2 of LTE support for V2X services |  | 205d? | 2015-09-07 A | 2016-06-17 A | 100% | finish no earlier than 2016-06-17 | S2 | 1640h | 1640h | FS_V2XARC | 36 | LG Electronics, LaeYoung Kim | laeyoung.kim@lge.com | Rel-14 | 70 |  |
| 3176 | 1303.6.3 | Study on Security of LTE support for V2X services |  | 205d? | 2015-09-07 A | 2016-06-17 A | 100% | finish no earlier than 2016-06-17 | S3 | 1640h | 1640h | FS_V2XARC_S3 | 36 |  |  | Rel-14 | 70 |  |
| 3177 | 1303.6.4 | RAN1 Study on LTE-based V2X Services |  | 263d? | 2015-06-15 A | 2016-06-15 A | 100% | finish no earlier than 2016-09-15 | R1 | 2104h | 2104h | FS_LTE_V2X | 35 | LG Electronics |  | Rel-14 | 68 |  |
| 3178 | 1304 | **Support for V2V services based on LTE sidelink** |  | 720d? | 2015-12-15 A | 2018-09-14 A | 100% |  |  | 8920h | 8920h | LTE_SL_V2V | 36 | LG Electronics |  | Rel-14 | 70 |  |
| 3179 | 1304.1 | Core part: Support for V2V services based on LTE sidelink |  | 199d? | 2015-12-15 A | 2016-09-15 A | 100% | finish no earlier than 2016-09-15 | R1 | 1592h | 1592h | LTE_SL_V2V-Core | 36 | LG Electronics |  | Rel-14 | 70 |  |
| 3180 | 1304.2 | Perf. part: Support for V2V services based on LTE sidelink |  | 394d? | 2015-12-15 A | 2017-06-15 A | 100% | finish no earlier than 2017-06-15 | R4 | 3152h | 3152h | LTE_SL_V2V-Perf | 36 | LG Electronics |  | Rel-14 | 70 |  |
| 3181 | 1304.3 | UE Conformance Test Aspects - Support for V2V services based on LTE sidelink |  | 522d? | 2016-09-15 A | 2018-09-14 A | 100% | finish no earlier than 2018-09-15 | R5 | 4176h | 4176h | LTE_SL_V2V-UEConTest | 37 | Huawei |  | Rel-14 | 73 |  |
| 3182 | 1305 | Release 14 on CIoT | milestone | 0d? | 2016-06-09 A | 2016-06-09 A | 100% | finish no earlier than 2016-06-09 |  |  |  |  |  |  |  | Rel-14 |  |  |
| 3183 | 1306 | **Non-IP for Cellular Internet of Things (CIoT) for 2G/3G-GPRS(EC-EGPRS)** |  | 143d? | 2016-03-02 A | 2016-09-15 A | 100% |  |  | 4040h | 4040h | NonIP_GPRS | 36 |  |  | Rel-14 | 71 |  |
| 3184 | 1306.1 | Non-IP for Cellular IoT for EC-EGPRS |  | 76d? | 2016-03-02 A | 2016-06-15 A | 100% | start no earlier than 2016-03-02 | S2 | 608h | 608h | NonIP_GPRS | 36 | Hans Ronneke, Ericsson | hans . Ronneke (a) ericsson . Com | Rel-14 | 71 |  |
| 3185 | 1306.2 | **CT aspects for Non-IP for Cellular Internet of Things for EC-EGPRS** |  | 143d? | 2016-03-02 A | 2016-09-15 A | 100% |  |  | 3432h | 3432h | NonIP_GPRS-CT | 36 | Orange, Youssef CHADLI | youssef.chadli@orange.com | Rel-14 | 71 |  |
| 3186 | 1306.2.1 | CT1 aspects for Non-IP for Cellular Internet of Things for EC-EGPRS |  | 143d? | 2016-03-02 A | 2016-09-15 A | 100% | finish no earlier than 2016-09-15 | C1 | 1144h | 1144h | NonIP_GPRS-CT | 36 | Orange, Youssef CHADLI | youssef.chadli@orange.com | Rel-14 | 71 |  |
| 3187 | 1306.2.2 | CT3 aspects for Non-IP for Cellular Internet of Things for EC-EGPRS |  | 143d? | 2016-03-02 A | 2016-09-15 A | 100% | finish no earlier than 2016-09-15 | C3 | 1144h | 1144h | NonIP_GPRS-CT | 37 | Orange, Youssef CHADLI | youssef.chadli@orange.com | Rel-14 | 72 |  |
| 3188 | 1306.2.3 | CT4 aspects for Non-IP for Cellular Internet of Things for EC-EGPRS |  | 143d? | 2016-03-02 A | 2016-09-15 A | 100% | finish no earlier than 2016-09-15 | C4 | 1144h | 1144h | NonIP_GPRS-CT | 36 | Orange, Youssef CHADLI | youssef.chadli@orange.com | Rel-14 | 71 |  |
| 3189 | 1307 | **Further enhanced MTC for LTE** |  | 589d? | 2016-06-15 A | 2018-09-14 A | 100% |  |  | 7344h | 7344h | LTE_feMTC | 37 | Ericsson |  | Rel-14 | 72 |  |
| 3190 | 1307.1 | Core part: Further enhanced MTC for LTE |  | 263d? | 2016-06-15 A | 2017-06-15 A | 100% | finish no earlier than 2017-06-15 | R1 | 2104h | 2104h | LTE_feMTC-Core | 37 | Ericsson |  | Rel-14 | 72 | RP-171441 |
| 3191 | 1307.2 | Perf. part: Further enhanced MTC for LTE |  | 394d? | 2016-06-15 A | 2017-12-15 A | 100% | finish no earlier than 2017-12-15 | R4 | 3152h | 3152h | LTE_feMTC-Perf | 37 | Ericsson |  | Rel-14 | 72 |  |
| 3192 | 1307.3 | UE Conformance Test Aspects - Further enhanced MTC for LTE |  | 261d? | 2017-09-15 A | 2018-09-14 A | 100% | finish no earlier than 2018-09-15 | R5 | 2088h | 2088h | LTE_feMTC-UEConTest | 39 | Ericsson |  | Rel-14 | 77 |  |
| 3193 | 1308 | **Enhancements of NB-IoT** |  | 654d? | 2016-06-15 A | 2018-12-14 A | 100% |  |  | 7864h | 7864h | NB_IOTenh | 37 | Huawei |  | Rel-14 | 72 |  |
| 3194 | 1308.1 | Core part: Enhancements of NB-IoT |  | 263d? | 2016-06-15 A | 2017-06-15 A | 100% | finish no earlier than 2017-06-15 | R1 | 2104h | 2104h | NB_IOTenh-Core | 37 | Huawei |  | Rel-14 | 72 | RP-171061 |
| 3195 | 1308.2 | Perf. part: Enhancements of NB-IoT |  | 394d? | 2016-06-15 A | 2017-12-15 A | 100% | finish no earlier than 2017-12-15 | R4 | 3152h | 3152h | NB_IOTenh-Perf | 37 | Huawei |  | Rel-14 | 72 |  |
| 3196 | 1308.3 | UE Conformance Test Aspects - Enhancements of NB-IoT |  | 326d? | 2017-09-15 A | 2018-12-14 A | 100% | finish no earlier than 2018-12-15 | R5 | 2608h | 2608h | NB_IOTenh-UEConTest | 39 | Huawei |  | Rel-14 | 77 |  |
| 3197 | 1309 | AT Commands for CIoT |  | 65d? | 2016-09-16 A | 2016-12-15 A | 100% | finish no earlier than 2016-12-15 | C1 | 520h | 520h | AT_CIoT | 37 | John-Luc Bakker |  | Rel-14 | 73 |  |

Notes:
- 3173: 1/4/15:TR number added¦June2015: Compl:25%->50¦07/09/15: 50%->75 / Impacted TSs and TRs: New 22.885
- 3174: 1/4/15:TR number added¦June2015: Compl:25%->50¦07/09/15: 50%->75¦7/12/15: 75%->100 / Impacted TSs and TRs: New 22.885
- 3175: 11/12/15: WID:SP-150625->SP-150743¦7/3/16: 10%->22¦7/3/16: WID:SP-150743->SP-150852¦9/6/16: 22%->80¦19/9/16: 80%->100 / Impacted TSs and TRs: 23.785
- 3176: Introduced at 100% completion, as per SA3 report to SA#76 / Impacted TSs and TRs: 33.885
- 3177: 29/09/15: Compl:0%->5% 29/09/15: Stat Rep: -->RP-151311 ¦28/1/16: 33.885 added;22/3/16: Compl:35%->50%22/3/16: CD:Wed 15/06/16->Thu 15/09/1622/3/16: WID: RP-15¦ / Impacted TSs and TRs: 33.885
- 3179: 22/3/16: Compl:0%->15%22/3/16: WID: RP-152293->RP-1606491/7/16: Compl:15%->60%1/7/16: WID: RP-160649->RP-161272¦28/7/16: 36.785 added¦26/9/16: Compl:60%->100%¦26/9/16: WID: RP-161272->RP-161603 / Impacted TSs and TRs: 36.785
- 3180: 22/3/16: WID: RP-152293->RP-1606491/7/16: WID: RP-160649->RP-16127226/9/16: WID: RP-161272->RP-161603¦20/12/16: Compl:0%->50% 21/3/17: Compl:50%->80% 21/3/17: CD:Wed 15/03/17->Thu 15/06/1719/6/17: Compl:80%->100%
- 3181: ¦20/12/16: Compl:0%->5% 21/3/17: Compl:5%->15%19/9/17: Compl:15%- 8/1/18: Com27/ ;; 11/10/20: 98%->100
- 3182: -
- 3184: 9/6/16: 0%->50¦19/9/16: 50%->100 / Impacted TSs and TRs: 23.060; 23.682; 23.401?
- 3185: 11/6/16: WID:CP-160161->CP-160293
- 3186: 11/6/16: 0%->50¦11/6/16: WID:CP-160161->CP-160293¦16/9/16: 50%->65¦2/12/16: 65%->100 / Impacted TSs and TRs: 24.008
- 3187: 11/6/16: WID:CP-160161->CP-160293¦13/6/16: 0%->65¦20/9/16: 0%->100 / Impacted TSs and TRs: 29.060; 29.274; 29.002; 29.303; 23.008; 29.128; 29.272; 23.007
- 3188: 11/6/16: WID:CP-160161->CP-160293¦13/6/16: 0%->65¦2/12/16: 65%->100 / Impacted TSs and TRs: 29.060; 29.274; 29.002; 29.303; 23.008; 29.128; 29.272; 23.007
- 3190: 26/9/16: Compl:0%->12%26/9/16: WID: RP-161321->RP-161464¦20/12/16: Compl:12%->70%¦20/12/16: WID: RP-161464->RP-16252021/3/17: Compl:70%->95% ¦21/3/17: CD19/6/17: Compl:95%->100%
- 3191: ¦26/9/16: WID: RP-161321->RP-161464¦20/12/16: WID: RP-161464->RP-162520¦20/12/16: Stat Rep: ->RP-16252021/3/17: CD:Fri 15/09/17->Fri 15/12/1721/3/17 19/6/17: Compl:0%->35%19/9/17: Compl:35%->60%¦8/1/18: Compl:60%->100%
- 3192: ¦8/1/18: Compl:0%->6%¦27/3/18: Compl:6%->21%¦ ¦2¦26/3/19: WID:RP-180414->RP-190514; 26/6/19: WID:RP-190514->RP-190935; 14/1/20: WID:RP-190935->RP-192886; 26/3/20: 26%->100
- 3194: 26/9/16: Compl:0%->13%26/9/16: WID: RP-161324->RP-161901¦20/12/16: Compl:13%->70%¦21/3/17: Compl:70%->95%¦21/3/17: CD:Wed 15/03/17->Thu 15/06/1719/6/17: Compl:95%->100%
- 3195: 26/9/16: WID: RP-161324->RP-16190121/3/17: CD:Fri 15/09/17->Fri 15/12/17¦19/6/17: Compl:0%->50%¦19/6/17: WID: RP-161901->RP-171060¦19/9/17: Compl:50%->60%¦8/1/18: Compl:60%->100%
- 3196: ¦8/1/18: Compl:0%->5%27/3/18: Compl:5%->30%¦27/6/18: C; 11/10/20: 60%->100
- 3197: 2/12/16: 10%->95¦6/3/17: 95%->100

| ID | WBS | Task | Duration | Start | Finish | Complete | Constraint | Resources | Work | Actual work | Acronym | PCG approved | WI rapporteur name | WI rapporteur e-mail | Release | TSG approved | Status Report | TSG stopped |
| --- | --- | --- | --- | --- | --- | --- | --- | --- | --- | --- | --- | --- | --- | --- | --- | --- | --- | --- |
| 3198 | 1310 | **Extended architecture support for Cellular Internet of Things** | 194d? | 2016-06-17 A | 2017-03-14 A | 100% |  |  | 3360h | 3360h | CIoT_Ext | 37 | Intel : Puneet Jain | puneet.jain@intel.com | Rel-14 | 73 |  |  |
| 3199 | 1310.1 | Study on extended architecture support for Cellular Internet of Things | 131d? | 2016-06-17 A | 2016-12-15 A | 100% | finish no earlier than 2016-12-15 | S2 | 1048h | 1048h | FS_CIoT_Ext | 37 | Intel : Puneet Jain | puneet.jain@intel.com | Rel-14 | 72 |  |  |
| 3200 | 1310.2 | Stage 2 of Extended architecture support for Cellular Internet of Things | 67d? | 2016-09-15 A | 2016-12-16 A | 100% | finish no earlier than 2016-12-16 | S2 | 536h | 536h | CIoT_Ext | 37 | Intel : Puneet Jain | puneet.jain@intel.com | Rel-14 | 73 |  |  |
| 3201 | 1310.3 | **Stage 3 of extended architecture enhancements for Cellular Internet of Things** | 74d? | 2016-12-01 A | 2017-03-14 A | 100% |  | ct | 1776h | 1776h | CIoT_Ext-CT | 38 | Intel, Vivek Gupta | vivek.g.gupta@intel.com | Rel-14 | 74 |  |  |
| 3202 | 1310.3.1 | CT1 aspects of extended architecture enhancements for Cellular Internet of Things | 74d? | 2016-12-01 A | 2017-03-14 A | 100% | finish no earlier than 2017-03-14 | C1 | 592h | 592h | CIoT_Ext-CT | 38 | Intel, Vivek Gupta | vivek.g.gupta@intel.com | Rel-14 | 74 |  |  |
| 3203 | 1310.3.2 | CT4 aspects of extended architecture enhancements for Cellular Internet of Things | 74d? | 2016-12-01 A | 2017-03-14 A | 100% | finish no earlier than 2017-03-14 | C4 | 592h | 592h | CIoT_Ext-CT | 38 | Intel, Vivek Gupta | vivek.g.gupta@intel.com | Rel-14 | 74 |  |  |
| 3204 | 1311 | **Radio Interface Enhancements for Extended Coverage GSM for support of Cellular Internet of Things** | 457d? | 2016-09-15 A | 2018-06-15 A | 100% |  | R6 | 5760h | 5760h | CIoT_EC_GSM_radio_enh | 37 | Nokia |  | Rel-14 | 73 |  |  |
| 3205 | 1311.1 | Core part: Radio Interface Enhancements for Extended Coverage GSM for support of Cellular Internet of Things | 196d? | 2016-09-15 A | 2017-06-15 A | 100% | finish no earlier than 2017-06-15 | R6 | 1568h | 1568h | CIoT_EC_GSM_radio_enh-Core | 37 | Nokia |  | Rel-14 | 73 | RP-171321 |  |
| 3206 | 1311.2 | Perf. part: Radio Interface Enhancements for Extended Coverage GSM for support of Cellular Internet of Things | 67d? | 2018-03-15 A | 2018-06-15 A | 100% |  | R6 | 536h | 536h | CIoT_EC_GSM_radio_enh-Perf | 37 | Nokia |  | Rel-14 | 73 |  |  |
| 3207 | 1312 | **New band support for Rel-14 Narrowband Internet of Things (NB-IOT)** | 262d? | 2016-09-15 A | 2017-09-15 A | 100% |  | R4 | 6296h | 6296h | NB_IOT_R14_bands | 37 | Ericsson |  | Rel-14 | 73 |  |  |
| 3208 | 1312.1 | Core part: New band support for Rel-14 Narrowband Internet of Things (NB-IOT) | 196d? | 2016-09-15 A | 2017-06-15 A | 100% | finish no earlier than 2017-06-15 | R4 | 1568h | 1568h | NB_IOT_R14_bands-Core | 37 | Ericsson |  | Rel-14 | 73 | RP-170970 |  |
| 3209 | 1312.2 | Perf. part: New band support for Rel-14 Narrowband Internet of Things (NB-IOT) | 196d? | 2016-09-15 A | 2017-06-15 A | 100% | finish no earlier than 2017-06-15 | R4 | 1568h | 1568h | NB_IOT_R14_bands-Perf | 37 | Ericsson |  | Rel-14 | 73 |  |  |
| 3210 | 1312.3 | UE Conformance Test Aspects - New band support for Rel-14 NB-IoT | 133d? | 2017-03-15 A | 2017-09-15 A | 100% | finish no earlier than 2017-12-15 | R5 | 1064h | 1064h | NB_IOT_R14_bands-UEConTest | 38 | Ericsson |  | Rel-14 | 75 |  |  |
| 3211 | 1313 | **Enhancements of Dedicated Core Networks selection mechanism** | 588d? | 2015-09-17 A | 2017-12-15 A | 100% |  |  | 7808h | 7808h | eDecor | 35 | Roland Gustafsson | Roland.Gustafsson@ericsson.com | Rel-14 | 69 | SP-170537 |  |
| 3212 | 1313.1 | Study on Enhancements of Dedicated Core Networks selection mechanism | 132d? | 2015-09-17 A | 2016-03-18 A | 100% | finish no earlier than 2016-03-18 | S2 | 1056h | 1056h | FS_eDecor | 35 | Roland Gustafsson | Roland.Gustafsson@ericsson.com | Rel-14 | 69 |  |  |
| 3213 | 1313.2 | Enhancements of Dedicated Core Networks selection mechanism | 72d? | 2016-06-09 A | 2016-09-15 A | 100% | finish no earlier than 2016-09-15 | S2 | 576h | 576h | eDecor | 37 | Roland Gustafsson | Roland.Gustafsson@ericsson.com | Rel-14 | 72 |  |  |
| 3214 | 1313.3 | **CT aspects of eDecor** | 65d? | 2016-09-16 A | 2016-12-15 A | 100% |  | ct | 2080h | 2080h | eDecor-CT | 37 | Mikael Wass | Mikael.wass@ericsson.com | Rel-14 | 73 |  |  |
| 3215 | 1313.3.1 | CT1 aspects of eDecor | 65d? | 2016-09-16 A | 2016-12-15 A | 100% | finish no earlier than 2016-12-15 | C1 | 520h | 520h | eDecor-CT | 37 | Mikael Wass | Mikael.wass@ericsson.com | Rel-14 | 73 |  |  |
| 3216 | 1313.3.2 | CT4 aspects of eDecor | 65d? | 2016-09-16 A | 2016-12-15 A | 100% | finish no earlier than 2016-12-15 | C4 | 520h | 520h | eDecor-CT | 37 | Mikael Wass | Mikael.wass@ericsson.com | Rel-14 | 73 |  |  |
| 3217 | 1313.3.3 | CT6 aspects of eDecor | 65d? | 2016-09-16 A | 2016-12-15 A | 100% | finish no earlier than 2016-12-15 | C6 | 520h | 520h | eDecor-CT | 37 | Mikael Wass | Mikael.wass@ericsson.com | Rel-14 | 73 |  |  |
| 3218 | 1313.4 | **RAN aspects of eDECOR for UMTS and LTE** | 262d? | 2016-12-15 A | 2017-12-15 A | 100% |  | R3 | 3672h | 3672h | eDECOR-UTRA_LTE | 38 | Ericsson |  | Rel-14 | 74 |  |  |
| 3219 | 1313.4.1 | Core part: RAN aspects of eDECOR for UMTS and LTE | 65d? | 2016-12-15 A | 2017-03-15 A | 100% | finish no earlier than 2017-03-15 | R3 | 520h | 520h | eDECOR-UTRA_LTE-Core | 38 | Ericsson |  | Rel-14 | 74 | RP-170547 |  |
| 3220 | 1313.4.2 | UE Conformance Test Aspects - Enhancements of Dedicated Core Networks for UTRA and LTE | 132d? | 2017-06-15 A | 2017-12-15 A | 100% | finish no earlier than 2017-12-15 | R5 | 1056h | 1056h | eDECOR-UTRA_LTE-UEConTest | 39 | Ericsson |  | Rel-14 | 76 |  |  |
| 3221 | 1313.5 | Stopped - GSM aspects of eDECOR | 53d? | 2017-04-04 A | 2017-06-15 A | 100% | start no earlier than 2017-04-04 | R6 | 424h | 424h | eDecor | 39 | Ericsson |  | Rel-14 | 76 |  | 80 |

Notes:
- 3198: Impacted TSs and TRs: 23.401; 23.682; 23.060
- 3199: 28/7/16: 23.730 added¦19/9/16: 0%->70¦1/12/16: FCD:03/17->12/16¦1/12/16: 70%->100 / Impacted TSs and TRs: 23.730
- 3200: 1/12/16: 0%->100¦1/12/16: WID:SP-160732->SP-160830 / Impacted TSs and TRs: 23.401; 23.682; 23.060; 23.271
- 3201: 21/3/17: 24.250 added; / Impacted TSs and TRs: 24.250
- 3202: 6/3/17: 0%->50¦5/6/17: 50%->100 / Impacted TSs and TRs: 24.301; 24.008
- 3203: 6/3/17: 0%->90¦5/6/17: 90%->100 / Impacted TSs and TRs: 23.008; 29.272; 29.002; 29.336; 29.128; 29.171; 29.172; 29.173
- 3205: ¦20/12/16: Compl:0%->50% 21/3/17: Compl:50%->80%19/6/17: Compl:80%->100%
- 3206: ¦20/12/16: Compl:0%->20% ¦21/3/17: Compl:20%->80%¦ 19/6/17: Compl:80%->100%
- 3208: ¦20/12/16: Compl:0%->99% 21/3/17: CD:Wed 15/03/17->Thu 15/06/17;19/6/17: Compl:99%->100%19/6/17: Stat Rep: ->RP-170970
- 3209: ¦20/12/16: Compl:0%->99% 21/3/17: Compl:99%->70% 19/6/17: Compl:70%->100%
- 3210: tested: REL-14 NB_IOT_R14_bands-Core (which got an exception at RAN #75 to still complete in REL-14 by RAN #76);
- 3211: 7/12/15: 0%->70¦7/3/16: 70%->80¦9/6/16: 80%->95 / Impacted TSs and TRs: 23.711
- 3212: 7/12/15: 0%->70¦7/3/16: 70%->80¦9/6/16: 80%->95¦19/9/16: 95%->100 / Impacted TSs and TRs: 23.711
- 3213: 19/9/16: 70%->100 / Impacted TSs and TRs: 23.401; 23.060; 23.251
- 3215: 2/12/16: 0%->80¦6/3/17: 80%->95¦5/6/17: 95%->100 / Impacted TSs and TRs: 24.301; 24.008; 24.368
- 3216: 2/12/16: 0%->10¦6/3/17: 10%->100 / Impacted TSs and TRs: 29.303; 23.003; 23.008
- 3217: 14/12/16: 0%->15¦7/3/17: 15%->85¦5/6/17: 85%->100 / Impacted TSs and TRs: 31.102; 31.111
- 3219: 21/3/17: Compl:0%->100%21/3/17: Stat Rep: ->RP-170547
- 3220: ¦19/9/17: Compl:0%->50%¦ 8/1/18: Compl:50%->100%
- 3221: Verbal addition by Paolo U. 21/09/17: verbal deletion by Paolo / Impacted TSs and TRs: 44.060; 44.018; 48.018

| ID | WBS | Task | Type | Duration | Start | Finish | Complete | Constraint | Resources | Work | Actual work | Acronym | PCG approved | WI rapporteur name | Release | TSG approved | Impacted TSs and TRs | WI rapporteur e-mail | TSG stopped | Status Report |
| --- | --- | --- | --- | --- | --- | --- | --- | --- | --- | --- | --- | --- | --- | --- | --- | --- | --- | --- | --- | --- |
| 3222 | 1314 | **Addition of band 25 and 26 to LTE MTC cat.0** |  | 65d? | 2016-12-15 A | 2017-03-15 A | 100% |  | R4 | 1040h | 1040h | LC_MTC_LTE_cat0_B25_B26 | 38 | Sprint | Rel-14 | 74 |  |  |  |  |
| 3223 | 1314.1 | Core part: Addition of band 25 and 26 to LTE MTC cat.0 |  | 65d? | 2016-12-15 A | 2017-03-15 A | 100% | finish no earlier than 2017-03-15 | R4 | 520h | 520h | LC_MTC_LTE_cat0_B25_B26-Core | 38 | Sprint | Rel-14 | 74 |  |  |  |  |
| 3224 | 1315 | Addition of bands 25 and 40 to LTE MTC cat.1 |  | 65d? | 2016-12-15 A | 2017-03-15 A | 100% | finish no earlier than 2017-03-15 | R4 | 520h | 520h | LTE_MTCe2_L1_cat1_B25_B40-Core | 38 | Sprint | Rel-14 | 74 |  |  |  |  |
| 3225 | 1316 | Release 14 on WLAN | milestone | 0d? | 2016-06-09 A | 2016-06-09 A | 100% | finish no earlier than 2016-06-09 |  |  |  |  |  |  | Rel-14 |  |  |  |  |  |
| 3226 | 1317 | **EIR check for WLAN access to EPC** |  | 230d? | 2015-11-02 A | 2016-09-15 A | 100% |  |  | 3000h | 3000h | EWE | 36 | Alcatel-Lucent, Nicolas Drevon | Rel-14 | 70 | 23.002; 23.402 | Nicolas.Drevon@alcatel-lucent.com |  |  |
| 3227 | 1317.1 | Stage 2 of EWE |  | 165d? | 2015-11-02 A | 2016-06-17 A | 100% | finish no earlier than 2016-06-17 | S2 | 1320h | 1320h | EWE | 36 | Alcatel-Lucent, Nicolas Drevon | Rel-14 | 70 | 23.002; 23.402 | Nicolas.Drevon@alcatel-lucent.com |  |  |
| 3228 | 1317.2 | **CT aspects of EWE** |  | 70d? | 2016-06-13 A | 2016-09-15 A | 100% |  | ct | 1680h | 1680h | EWE-CT | 37 | Nokia, Bruno Landais | Rel-14 | 72 |  | bruno.landais@nokia.com |  |  |
| 3229 | 1317.2.1 | CT1 aspects of EWE |  | 70d? | 2016-06-13 A | 2016-09-15 A | 100% | finish no earlier than 2016-09-15 | C1 | 560h | 560h | EWE-CT | 37 | Nokia, Bruno Landais | Rel-14 | 72 | 24.302 | bruno.landais@nokia.com |  |  |
| 3230 | 1317.2.2 | CT4 aspects of EWE |  | 70d? | 2016-06-13 A | 2016-09-15 A | 100% | finish no earlier than 2016-09-15 | C4 | 560h | 560h | EWE-CT | 37 | Nokia, Bruno Landais | Rel-14 | 72 | 29.273 | bruno.landais@nokia.com |  |  |
| 3231 | 1318 | **Support of EAP Re-authentication Protocol for WLAN Interworking** |  | 130d? | 2016-09-16 A | 2017-03-16 A | 100% |  |  | 4152h | 4152h | ERP | 37 | ORANGE, Todor Gamishev | Rel-14 | 73 |  | Todor dot Gamishev at Orange dot com |  |  |
| 3232 | 1318.1 | Support of EAP Re-authentication Protocol for WLAN Interworking |  | 129d? | 2016-09-16 A | 2017-03-15 A | 100% | finish no earlier than 2017-03-15 | S3 | 1032h | 1032h | ERP | 37 | ORANGE, Todor Gamishev | Rel-14 | 73 | 33.402 | Todor dot Gamishev at Orange dot com |  |  |
| 3233 | 1318.2 | **CT aspects of ERP** |  | 130d? | 2016-09-16 A | 2017-03-16 A | 100% |  | ct | 3120h | 3120h | ERP-CT | 37 | Orange, Julien Bournelle | Rel-14 | 73 |  | Julien.bournelle@orange.com |  |  |
| 3234 | 1318.2.1 | CT1 aspects of ERP |  | 130d? | 2016-09-16 A | 2017-03-16 A | 100% | finish no earlier than 2017-03-16 | C1 | 1040h | 1040h | ERP-CT | 37 | Orange, Julien Bournelle | Rel-14 | 73 | 24.302 | Julien.bournelle@orange.com |  |  |
| 3235 | 1318.2.2 | CT4 aspects of ERP |  | 130d? | 2016-09-16 A | 2017-03-16 A | 100% | finish no earlier than 2017-03-16 | C4 | 1040h | 1040h | ERP-CT | 37 | Orange, Julien Bournelle | Rel-14 | 73 | 29.273; 23.008; 23.003 | Julien.bournelle@orange.com |  |  |
| 3236 | 1319 | **Phase 2 of the Support of Emergency services over WLAN** |  | 403d? | 2015-09-01 A | 2017-03-15 A | 100% |  |  | 5328h | 5328h | SEW2 | 37 | Nicolas Drevon | Rel-14 | 72 | new 23.771; 23.402; 23.167 | nicolas.drevon@nokia.com |  |  |
| 3237 | 1319.1 | Study on Phase 2 of the Support of Emergency services over WLAN |  | 208d? | 2015-09-01 A | 2016-06-16 A | 100% | finish no earlier than 2016-06-16 | S2 | 1664h | 1664h | FS_SEW2 | 34 | Laurent Thiebaut, Alcatel Lucent | Rel-14 | 67 | new 23.771 | Laurent.thiebaut@alcatel-lucent.com |  |  |
| 3238 | 1319.2 | Support of Emergency services over WLAN - phase 2 |  | 70d? | 2016-06-13 A | 2016-09-15 A | 100% | finish no earlier than 2016-09-15 | S2 | 560h | 560h | SEW2 | 37 | Nicolas Drevon | Rel-14 | 72 | 23.402; 23.167 | nicolas.drevon@nokia.com |  |  |
| 3239 | 1319.3 | **CT aspects of SEW2** |  | 129d? | 2016-09-16 A | 2017-03-15 A | 100% |  | ct | 3104h | 3104h | SEW2-CT | 37 | Jennifer Liu | Rel-14 | 73 |  | jennifer.liu@nokia.com |  |  |
| 3240 | 1319.3.1 | CT1 aspects of SEW2 |  | 129d? | 2016-09-16 A | 2017-03-15 A | 100% | finish no earlier than 2017-03-15 | C1 | 1032h | 1032h | SEW2-CT | 37 | Jennifer Liu | Rel-14 | 73 | 24.302; 24.312; 24.301; 24.244; 24.229; 24.237 | jennifer.liu@nokia.com |  |  |
| 3241 | 1319.3.2 | CT4 aspects of SEW2 |  | 129d? | 2016-09-16 A | 2017-03-15 A | 100% | finish no earlier than 2017-03-15 | C4 | 1032h | 1032h | SEW2-CT | 37 | Jennifer Liu | Rel-14 | 73 | 23.003; 29.272; 29.273; 29.274; 29.328 | jennifer.liu@nokia.com |  |  |
| 3242 | 1319.3.3 | Stopped - CT6 aspects of SEW2 |  | 1d? | 2016-12-14 A | 2016-12-14 A | 100% | finish no earlier than 2016-12-14 | C6 | 8h | 8h | SEW2-CT | 37 | Jennifer Liu | Rel-14 | 73 | 31.102 | jennifer.liu@nokia.com | 80 |  |
| 3243 | 1320 | T-ADS supporting WLAN Access |  | 134d? | 2016-03-15 A | 2016-09-15 A | 100% | finish no earlier than 2016-09-15 | S2 | 1072h | 1072h | TADS_WLAN | 37 | Jiang Yi | Rel-14 | 72 | 23.292; 23.221; 23.402 | jiangyi (at) chinamobile (dot) com |  | SP-170519 |
| 3244 | 1321 | **Enhanced LTE-WLAN Aggregation (LWA)** |  | 263d? | 2016-03-15 A | 2017-03-15 A | 100% |  | R2 | 4208h | 4208h | LTE_WLAN_aggr | 36 | Intel | Rel-14 | 71 |  |  |  |  |
| 3245 | 1321.1 | Core part: Enhanced LTE-WLAN Aggregation (LWA) |  | 263d? | 2016-03-15 A | 2017-03-15 A | 100% | finish no earlier than 2017-03-15 | R2 | 2104h | 2104h | LTE_WLAN_aggr-Core | 36 | Intel | Rel-14 | 71 |  |  |  | RP-170330 |
| 3246 | 1322 | Release 14 on IMS | milestone | 0d? | 2016-06-09 A | 2016-06-09 A | 100% | finish no earlier than 2016-06-09 |  |  |  |  |  |  | Rel-14 |  |  |  |  |  |

Notes:
- 3223: ¦21/3/17: Compl:0%->100%
- 3224: ¦21/3/17: Compl:0%->100%
- 3225: -
- 3226: 7/3/16: 45%->60¦9/6/16: 60%->100
- 3227: 7/3/16: 45%->60¦9/6/16: 60%->100
- 3229: 16/9/16: 0%->100
- 3230: 2/12/16: 0%->100
- 3232: 1/12/16: 0%->90¦6/3/17: 90%->100
- 3234: 2/12/16: 0%->80¦6/3/17: 80%->95¦5/6/17: 95%->100
- 3235: 2/12/16: 0%->50¦6/3/17: 50%->95¦5/6/17: 95%->100
- 3237: June2015: Compl:0%->100, SP-150151->SP-150251¦7/12/15: 0%->30, FCD: 12/15->06/16¦7/3/16: 30%->75¦7/3/16: WID:SP-150251->SP-160173¦9/6/16: 75%->100
- 3238: 11/6/16: 0%->45¦19/9/16: 45%->100
- 3239: 5/12/16: WID:CP-160476->CP-160694
- 3240: 2/12/16: 20%->95¦5/6/17: 95%->100
- 3241: 2/12/16: 0%->100
- 3242: Deleted at CT6#82
- 3243: 19/9/16: 0%->100
- 3244: follow-up WI of REL-13 WI LTE_WLAN_radio¦no Perf. part
- 3245: follow-up WI of REL-13 WI LTE_WLAN_radio¦no Perf. part1/7/16: Compl:0%->25%1/7/16: WID: RP-160600->RP-160923¦26/9/16: Compl:25%->45%¦20/12/16: Compl:45%->75%¦20/12/16: Stat Rep: --> ¦21/3/17: Compl:75%->100% ¦21/3/17
- 3246: -

| ID | WBS | Task | Type | Duration | Start | Finish | Complete | Baseline start | Baseline finish | Baseline duration | Constraint | Resources | Work | Actual work | Acronym | PCG approved | Impacted TSs and TRs | WI rapporteur name | Release | TSG approved | Status Report | WI rapporteur e-mail | MCC resp | Acronym_3GU_Export |
| --- | --- | --- | --- | --- | --- | --- | --- | --- | --- | --- | --- | --- | --- | --- | --- | --- | --- | --- | --- | --- | --- | --- | --- | --- |
| 3247 | 1323 | **Evolution to and Interworking with eCall in IMS** |  | 745d? | 2015-05-11 A | 2018-03-15 A | 100% |  |  |  |  |  | 6288h | 6288h | EIEI | 35 | 22.101 | Kurt Bischinger | Rel-14 | 68 | SP-170538 |  |  |  |
| 3248 | 1323.1 | Stage 1 of Evolution to and Interworking with eCall in IMS |  | 30d? | 2015-05-11 A | 2015-06-19 A | 100% |  |  |  | start no earlier than 2015-05-11 | S1 | 240h | 240h | EIEI | 35 | 22.101 | Kurt Bischinger | Rel-14 | 68 |  |  |  |  |
| 3249 | 1323.2 | Stage 2 of Evolution to and Interworking with eCall in IMS |  | 131d? | 2015-12-11 A | 2016-06-10 A | 100% |  |  |  | finish no earlier than 2016-06-10 | S2 | 1048h | 1048h | EIEI | 35 | 23.167; 23.401 | Haris Zisimopoulos, Qualcomm Incorporated | Rel-14 | 68 |  | harisz@qti.qualcomm.com |  |  |
| 3250 | 1323.3 | **CT aspects of evolution to and interworking with eCall in IMS** |  | 143d? | 2016-03-02 A | 2016-09-15 A | 100% |  |  |  |  |  | 3432h | 3432h | EIEI-CT | 36 |  | Lena Chaponniere | Rel-14 | 71 |  | lguellec@qti.qualcomm.com |  |  |
| 3251 | 1323.3.1 | CT1 aspects of evolution to and interworking with eCall in IMS |  | 143d? | 2016-03-02 A | 2016-09-15 A | 100% |  |  |  | finish no earlier than 2016-09-15 | C1 | 1144h | 1144h | EIEI-CT | 36 | 24.229; 24.301 | Lena Chaponniere | Rel-14 | 71 |  | lguellec@qti.qualcomm.com |  |  |
| 3252 | 1323.3.2 | (IETF) Next-Generation Pan-European eCall (draft-ietf-ecrit-ecall) |  | 143d? | 2016-03-02 A | 2016-09-15 A | 100% |  |  |  | finish no earlier than 2016-09-15 | C1-IETF | 1144h | 1144h | EIEI-CT | 37 | draft-ietf-ecrit-ecall; RFC 8147 |  | Rel-14 | 72 |  |  |  |  |
| 3253 | 1323.3.3 | CT6 aspects of evolution to and interworking with eCall in IMS |  | 143d? | 2016-03-02 A | 2016-09-15 A | 100% |  |  |  | finish no earlier than 2016-09-15 | C6 | 1144h | 1144h | EIEI-CT | 36 | 31.102 | Lena Chaponniere | Rel-14 | 71 |  | lguellec@qti.qualcomm.com |  |  |
| 3254 | 1323.4 | UE Conformance Test Aspects - Evolution to and Interworking with eCall in IMS (EIEI) |  | 196d? | 2017-06-15 A | 2018-03-15 A | 100% |  |  |  | finish no earlier than 2018-03-15 | R5 | 1568h | 1568h | EIEI-UEConTest | 39 |  | Qualcomm | Rel-14 | 76 |  |  |  |  |
| 3255 | 1324 | **Password based service activation for IMS Multimedia Telephony service** |  | 463d? | 2015-03-11 A | 2016-12-15 A | 100% |  |  |  |  |  | 3264h | 3264h | PWDIMS | 34 | 22.173 | Peter Bleckert (Ericsson) | Rel-14 | 67 | SP-170536 |  |  |  |
| 3256 | 1324.1 | Stage 1 for PWDIMS |  | 3d? | 2015-03-11 A | 2015-03-13 A | 100% |  |  |  | finish no earlier than 2015-03-13 | S1 | 24h | 24h | PWDIMS | 34 | 22.173 | Peter Bleckert (Ericsson) | Rel-14 | 67 |  |  |  |  |
| 3257 | 1324.2 | **CT aspects for PWDIMS** |  | 135d? | 2016-06-13 A | 2016-12-15 A | 100% |  |  |  |  | ct | 3240h | 3240h | PWDIMS-CT | 37 |  | Axell, Jörgen | Rel-14 | 72 |  |  |  |  |
| 3258 | 1324.2.1 | CT1 aspects for PWDIMS |  | 135d? | 2016-06-13 A | 2016-12-15 A | 100% |  |  |  | finish no earlier than 2016-12-15 | C1 | 1080h | 1080h | PWDIMS-CT | 37 | 24.623; 24.611 | Axell, Jörgen | Rel-14 | 72 |  |  |  |  |
| 3259 | 1324.2.2 | CT3 aspects for PWDIMS |  | 135d? | 2016-06-13 A | 2016-12-15 A | 100% |  |  |  | finish no earlier than 2016-12-15 | C3 | 1080h | 1080h | PWDIMS-CT | 37 | 29.292 | Axell, Jörgen | Rel-14 | 72 |  |  |  |  |
| 3260 | 1325 | **IMS Signalling Activated Trace** |  | 531d? | 2014-03-05 A | 2016-03-11 A | 100% | 2014-03-05 | 2014-09-12 | 138d? |  |  | 22056h | 22056h | ISAT | 32 |  | Vodafone | Rel-14 | 63 |  | peter.dawes @vodafone.com | Frederic | ISAT |
| 3261 | 1325.1 | CT1 part of IMS Signalling Activated Trace |  | 528d? | 2014-03-10 A | 2016-03-11 A | 100% | 2014-03-05 | 2014-09-12 | 138d? | finish no earlier than 2016-03-11 | C1 | 4224h | 4224h | ISAT | 32 | 24.229; 24.323 | Vodafone | Rel-14 | 63 |  | peter.dawes @vodafone.com | Frederic |  |
| 3262 | 1325.2 | (IETF) IMS Signalling Activated Trace (draft-ietf-insipid-logme-marking) --> RFC 8497 |  | 391d? | 2014-09-12 A | 2016-03-11 A | 100% |  |  |  | finish no earlier than 2016-03-11 | C1-IETF | 3128h | 3128h | ISAT | 33 | draft-dawes-sipping-debug | Vodafone | Rel-14 | 65 |  | peter.dawes @vodafone.com |  |  |
| 3263 | 1325.3 | (IETF) IMS Signalling Activated Trace (draft-ietf-insipid-logme-marking) --> RFC 8497 |  | 391d? | 2014-09-12 A | 2016-03-11 A | 100% |  |  |  | finish no earlier than 2016-03-11 | C3-IETF | 3128h | 3128h | ISAT | 33 | draft-dawes-sipping-debug | Vodafone | Rel-14 | 65 |  | peter.dawes @vodafone.com |  |  |
| 3264 | 1325.4 | (IETF) IMS Signalling Activated Trace (draft-ietf-insipid-logme-marking) --> RFC 8497 |  | 391d? | 2014-09-12 A | 2016-03-11 A | 100% |  |  |  | finish no earlier than 2016-03-11 | C4-IETF | 3128h | 3128h | ISAT | 33 | draft-dawes-sipping-debug | Vodafone | Rel-14 | 65 |  | peter.dawes @vodafone.com |  |  |
| 3265 | 1325.5 | CT3 part of IMS Signalling Activated Trace |  | 528d? | 2014-03-10 A | 2016-03-11 A | 100% | 2014-03-05 | 2014-06-13 | 73d? | finish no earlier than 2016-03-11 | C3 | 4224h | 4224h | ISAT | 32 | 29.165 | Vodafone | Rel-14 | 63 |  | peter.dawes @vodafone.com | Adrian |  |
| 3266 | 1325.6 | CT4 part of IMS Signalling Activated Trace |  | 528d? | 2014-03-05 A | 2016-03-11 A | 100% | 2014-03-05 | 2014-09-12 | 138d? | finish no earlier than 2016-03-11 | C4 | 4224h | 4224h | ISAT | 32 | 23.008; 29.228; 29.229; 29.328; 29.329 | Vodafone | Rel-14 | 63 |  | peter.dawes @vodafone.com | Kimmo |  |
| 3267 | 1326 | Other Release 14 | milestone | 0d? | 2016-06-09 A | 2016-06-09 A | 100% |  |  |  | finish no earlier than 2016-06-09 |  |  |  |  |  |  |  | Rel-14 |  |  |  |  |  |
| 3268 | 1327 | **User Controlled Spoofed Call Treatment** |  | 474d? | 2016-08-23 A | 2018-06-15 A | 100% |  |  |  |  |  | 2856h | 2856h | SPECTRE | 37 |  | Greg Schumacher, Sprint | Rel-14 | 73 |  |  |  |  |
| 3269 | 1327.1 | Stage 1 of User Controlled Spoofed Call Treatment |  | 20d? | 2016-08-23 A | 2016-09-19 A | 100% |  |  |  | finish no earlier than 2016-09-19 | S1 | 160h | 160h | SPECTRE | 37 | 22.228; 22.173 | Greg Schumacher, Sprint | Rel-14 | 73 |  |  |  |  |
| 3270 | 1327.2 | Stage 3 of User Controlled Spoofed Call Treatment |  | 74d? | 2016-12-01 A | 2017-03-14 A | 100% |  |  |  | finish no earlier than 2017-03-14 | C1 | 592h | 592h | SPECTRE-CT | 38 | 24.229; 29.165 | Dolly, Martin | Rel-14 | 74 |  | md3135@att.com |  |  |
| 3271 | 1327.3 | (IETF) A SIP Response Code for Unwanted Calls (draft-ietf-sipcore-status-unwanted) |  | 1d? | 2017-03-14 A | 2017-03-14 A | 100% |  |  |  | finish no earlier than 2017-03-14 | C1-IETF | 8h | 8h | SPECTRE-CT_IETF | 38 | RFC 8197 | Ericsson | Rel-14 | 75 |  |  |  |  |
| 3272 | 1327.4 | (IETF) Authenticated Identity Management in SIP (draft-ietf-stir-rfc4474bis) |  | 262d? | 2017-06-15 A | 2018-06-15 A | 100% |  |  |  | finish no earlier than 2018-06-15 | C1-IETF | 2096h | 2096h | SPECTRE-CT_IETF2 | 40 | RFC 8224 | Christer Holmberg | Rel-14 | 78 |  | christer.holmberg@ericsson.com |  |  |

Notes:
- 3247: 12/15: created by MCC to distinguish Stage 1 from Stage 2
- 3249: 7/3/16: 0%->20¦9/6/16: 20%->100. FCD: 03/16->06/16
- 3251: 11/6/16: 0%->35¦16/9/16: 35%->85¦2/12/16: 85%->100
- 3252: 18/12/17: 30%->100; 9/4/21: RFC 8147 added;
- 3253: 16/9/16: 0%->100
- 3254: ¦19/9/17: Compl:0%->45%¦8/1/18: Compl:45%->80%¦27/3/18: Compl:80%->100%
- 3255: 1/4/15: rapporteur added, Impacted TS added. 31/07/15: 100%
- 3256: 1/4/15: rapporteur added, Impacted TS added. 31/07/15: 100%
- 3258: 2/12/16: 0%->15¦6/3/17: 15%->100
- 3259: 5/6/17: 0%->100
- 3260: Mar 15: WID: CP-140195->CP-150091. ES in CP-150637. 8/3/16: Moved from Rel-13 at CT#71
- 3261: CP66: moved to Rel-13. Mar 15: WID: CP-140195->CP-150091. ES in CP-150728¦5/6/17: 0%->100
- 3262: CP66: moved to Rel-13. Mar 15: WID: CP-140195->CP-150091. ES in CP-150637¦13/6/16: 25%->28; 26/6/19: 28%->100
- 3263: CP66: moved to Rel-13. Mar 15: WID: CP-140195->CP-150091. ES in CP-150637; 26/6/19: 25%->100
- 3264: CP66: moved to Rel-13. Mar 15: WID: CP-140195->CP-150091. ES in CP-150637¦5/6/17: 25%->70; 26/6/19: 70%->100
- 3265: CP66: moved to Rel-13. Mar 15: WID: CP-140195->CP-150091. ES in CP-150637¦5/6/17: 0%->100
- 3266: CP66: moved to Rel-13. Mar.15: 90%. ES in CP-150615. 7/3/16: Rel-13->Rel-14¦5/6/17: 90%->100
- 3267: -
- 3268: 1/12/16: moved from Rel-15 to Rel-14¦1/12/16: WID:SP-160729->SP-160898
- 3269: 1/12/16: moved from Rel-15 to Rel-14¦1/12/16: WID:SP-160729->SP-160898
- 3270: 2/12/16: 0%->25¦6/3/17: 25%->100
- 3271: 18/12/17: 20%->100; 9/4/21: RFC 8197 added;
- 3272: 22/3/18: 0%->100; 9/4/21: RFC 8224 added;

| ID | WBS | Task | Duration | Start | Finish | Complete | Constraint | Resources | Work | Actual work | Acronym | PCG approved | WI rapporteur name | WI rapporteur e-mail | Release | TSG approved | Status Report |
| --- | --- | --- | --- | --- | --- | --- | --- | --- | --- | --- | --- | --- | --- | --- | --- | --- | --- |
| 3273 | 1328 | **Enhancement for TV service** | 565d? | 2015-04-14 A | 2017-06-09 A | 100% |  |  | 7800h | 7800h | EnTV | 36 | Zhiming Li | Lizhiming@huawei.com | Rel-14 | 70 | SP-170532 |
| 3274 | 1328.1 | Study on 3GPP Enhancement for TV Video service | 176d? | 2015-04-14 A | 2015-12-15 A | 100% | finish no earlier than 2015-12-15 | S1 | 1408h | 1408h | FS_EnTV | 34 | Zhiming Li (Huawei) | lizhiming@huawei.com | Rel-14 | 67 |  |
| 3275 | 1328.2 | **System Architecture Enhancements to eMBMS for TV Video Service** | 201d? | 2016-03-11 A | 2016-12-15 A | 100% |  |  | 1736h | 1736h | AE_enTV | 36 |  |  | Rel-14 | 71 |  |
| 3276 | 1328.2.1 | Study on System Architecture Enhancements to eMBMS for TV Video Service | 136d? | 2016-03-11 A | 2016-09-15 A | 100% | finish no earlier than 2016-09-15 | S2 | 1088h | 1088h | FS_AE_enTV | 36 | Miguel Griot, Qualcomm | mgriot@qti.qualcomm.com | Rel-14 | 71 |  |
| 3277 | 1328.2.2 | System Architecture Enhancements for TV service | 81d? | 2016-08-25 A | 2016-12-15 A | 100% | finish no earlier than 2016-12-15 | S2 | 648h | 648h | AE_enTV | 37 | Miguel Griot, Qualcomm | mgriot@qti.qualcomm.com | Rel-14 | 73 |  |
| 3278 | 1328.3 | Mobile Network Interface for MBMS Delivery of Media and TV services | 80d? | 2016-08-22 A | 2016-12-09 A | 100% | finish no earlier than 2016-12-09 | S4 | 640h | 640h | AE_enTV-MI_MTV | 37 | Thorsten Lohmar | Thorsten.lohmar@ericsson.com | Rel-14 | 73 |  |
| 3279 | 1328.4 | Codec aspects for eMBMS Delivery of Media and TV Services | 132d? | 2016-12-08 A | 2017-06-09 A | 100% | finish no earlier than 2017-06-09 | S4 | 1056h | 1056h | AE_enTV-S4 | 38 | Imed Bouazizi | i.bouazizi@samsung.com | Rel-14 | 74 |  |
| 3280 | 1328.5 | **Stage 3 of system architecture enhancements for TV service** | 74d? | 2016-12-01 A | 2017-03-14 A | 100% |  | ct | 2960h | 2960h | AE_enTV-CT | 38 | Catovic, Amer | amerc@qti.qualcomm.com | Rel-14 | 74 |  |
| 3281 | 1328.5.1 | CT1 aspects of system architecture enhancements for TV service | 74d? | 2016-12-01 A | 2017-03-14 A | 100% | finish no earlier than 2017-03-14 | C1 | 592h | 592h | AE_enTV-CT | 38 | Catovic, Amer | amerc@qti.qualcomm.com | Rel-14 | 74 |  |
| 3282 | 1328.5.2 | CT3 aspects of system architecture enhancements for TV service | 74d? | 2016-12-01 A | 2017-03-14 A | 100% | finish no earlier than 2017-03-14 | C3 | 592h | 592h | AE_enTV-CT | 38 | Catovic, Amer | amerc@qti.qualcomm.com | Rel-14 | 74 |  |
| 3283 | 1328.5.3 | CT4 aspects of system architecture enhancements for TV service | 74d? | 2016-12-01 A | 2017-03-14 A | 100% | finish no earlier than 2017-03-14 | C4 | 592h | 592h | AE_enTV-CT | 38 | Catovic, Amer | amerc@qti.qualcomm.com | Rel-14 | 74 |  |
| 3284 | 1328.5.4 | CT6 aspects of system architecture enhancements for TV service | 74d? | 2016-12-01 A | 2017-03-14 A | 100% | finish no earlier than 2017-03-14 | C6 | 592h | 592h | AE_enTV-CT | 38 | Catovic, Amer | amerc@qti.qualcomm.com | Rel-14 | 74 |  |
| 3285 | 1329 | MBMS Transport Protocol and APIs | 330d? | 2015-12-11 A | 2017-03-15 A | 100% | finish no earlier than 2017-03-15 | S4 | 2640h | 2640h | TRAPI | 36 | Samsung, Imed Bouazizi | i.bouazizi@samsung.com | Rel-14 | 70 |  |
| 3286 | 1330 | Multimedia Priority Service Modifications | 331d? | 2015-03-11 A | 2016-06-15 A | 100% | finish no earlier than 2016-06-15 | S1 | 2648h | 2648h | MPS_Mods | 34 | Ray P. Singh (Applied Communications Science) | rsingh@appcomsci.com | Rel-14 | 67 |  |
| 3287 | 1331 | Lawful Interception Rel-14 | 394d? | 2016-06-15 A | 2017-12-15 A | 100% | finish no earlier than 2017-12-15 | S3LI | 3152h | 3152h | LI14 | 37 | Koen JASPERS, PIDS |  | Rel-14 | 72 |  |
| 3288 | 1332 | **SIP Reason header extension** | 455d? | 2016-09-16 A | 2018-06-14 A | 100% |  | ct | 7792h | 7792h | REAS_EXT | 37 | Mohali, Marianne | marianne.mohali@orange.com | Rel-14 | 73 | CP-171175 |
| 3289 | 1332.1 | CT1 aspects of SIP Reason header extension | 129d? | 2016-09-16 A | 2017-03-15 A | 100% | finish no earlier than 2017-03-15 | C1 | 1032h | 1032h | REAS_EXT | 37 | Mohali, Marianne | marianne.mohali@orange.com | Rel-14 | 73 |  |
| 3290 | 1332.2 | (IETF) ISUP Cause Location Parameter for the SIP Reason Header Field (draft-ietf-sipcore-reason-q850-loc) --> RFC 8606 | 261d? | 2017-06-15 A | 2018-06-14 A | 100% | finish no earlier than 2018-06-14 | C1-IETF | 2088h | 2088h | REAS_EXT | 40 | Michael KREIPL, Deutsche Telekom | michael(dot)kreipl(at)telekom(dot)de | Rel-14 | 78 |  |
| 3291 | 1332.3 | CT3 aspects of SIP Reason header extension | 129d? | 2016-09-16 A | 2017-03-15 A | 100% | finish no earlier than 2017-03-15 | C3 | 1032h | 1032h | REAS_EXT | 37 | Mohali, Marianne | marianne.mohali@orange.com | Rel-14 | 73 |  |
| 3292 | 1333 | Enhancements to User Location Reporting Support | 73d? | 2015-09-09 A | 2015-12-18 A | 100% | finish no earlier than 2015-12-18 | S1 | 584h | 584h | eULRS | 35 |  |  | Rel-14 | 68 |  |
| 3293 | 1334 | **Diameter Load Control Mechanism** | 597d? | 2014-12-03 A | 2017-03-15 A | 100% |  | ct | 8032h | 8032h | DLoCMe | 37 | Nokia, Ulrich Wiehe | ulrich.wiehe@nokia.com | Rel-14 | 73 | CP-171049 |
| 3294 | 1334.1 | CT3 aspects of Diameter Load Control Mechanism | 65d? | 2016-09-16 A | 2016-12-15 A | 100% | finish no earlier than 2016-12-15 | C3 | 520h | 520h | DLoCMe | 37 | Nokia, Ulrich Wiehe | ulrich.wiehe@nokia.com | Rel-14 | 73 |  |
| 3295 | 1334.2 | CT4 aspects of Diameter Load Control Mechanism | 65d? | 2016-09-16 A | 2016-12-15 A | 100% | finish no earlier than 2016-12-15 | C4 | 520h | 520h | DLoCMe | 37 | Nokia, Ulrich Wiehe | ulrich.wiehe@nokia.com | Rel-14 | 73 |  |
| 3296 | 1334.3 | (IETF) Diameter Load Information Conveyance (draft-ietf-dime-load) --> RFC 8583 | 74d? | 2016-12-02 A | 2017-03-15 A | 100% | finish no earlier than 2017-03-15 | C4-IETF | 592h | 592h | DLoCMe | 38 |  |  | Rel-14 | 74 |  |
| 3297 | 1334.4 | Study on Diameter Load Control Mechanisms | 203d? | 2014-12-03 A | 2015-09-11 A | 100% | finish no earlier than 2015-09-11 | C4 | 1624h | 1624h | FS_DLoCME | 34 | Alcatel-Lucent |  | Rel-13 | 66 |  |

Notes:
- 3273: 2/3/16: 0%->100 / Impacted TSs and TRs: 22.101
- 3274: 1/4/15:TR number added¦June2015: Compl:0%->20¦07/09/15: 20%->75¦7/12/15: 75%->100 / Impacted TSs and TRs: 22.816
- 3276: 9/6/16: 0%->70¦28/7/16: 23.746 added¦19/9/16: 70%->100 / Impacted TSs and TRs: 23.746
- 3277: 19/9/16: 0%->85¦1/12/16: FCD:09/16->12/16¦1/12/16: 85%->100 / Impacted TSs and TRs: 23.246
- 3278: 06/10/16: Acronym: SA_enTV-MI_MTV -> AE_enTV-MI_MTV¦1/12/16: FCD:09/16->2/16¦1/12/16: 0%->50¦8/12/16: 50%->100 / Impacted TSs and TRs: 26.346
- 3279: 6/3/17: 0%->20¦6/3/17: FCD:03/17->06/17¦7/6/17: 20%->100 / Impacted TSs and TRs: 26.347; 26.346
- 3280: 21/3/17: 29.116 added; / Impacted TSs and TRs: 24.116; 24.117; 29.116
- 3281: 2/12/16: 0%->40¦6/3/17: 40%->75¦5/6/17: 75%->100 / Impacted TSs and TRs: 24.008
- 3282: 6/3/17: 0%->80¦6/3/17: 80%->100 / Impacted TSs and TRs: 29.061
- 3283: 5/6/17: 0%->100 / Impacted TSs and TRs: 29.274; 23.003
- 3284: 7/3/17: 0%->100 / Impacted TSs and TRs: 31.102
- 3285: 28/1/16: 26.347 added¦7/3/16: 0%->20¦11/6/16: 20%->35¦19/9/16: 35%->60. FCD: 09/16->03/17¦1/12/16: 60%->70¦6/3/17: 70%->100 / Impacted TSs and TRs: 26.346; 26.852; New TS; 26.347
- 3286: 1/4/15: rapporteur added, Impacted TS added. 6/15: 0->25%¦07/09/15: 25%->40¦7/12/15: 40%->70¦2/3/16: 70%->80¦9/6/16: 80%->100 / Impacted TSs and TRs: 22.153
- 3287: 1/12/16: 0%->10¦2/3/17: WID:SP-160375->SP-1570038¦3/3/17: 8%->15¦6/3/17: 15%->20¦9/3/17: WID:SP-1570038->SP-170038¦7/6/17: 20%->50¦11/9/17: 50%->80¦15/12/17: 80%->100
- 3289: 2/12/16: 0%->50¦6/3/17: 50%->85¦5/6/17: 85%->100 / Impacted TSs and TRs: 24.229
- 3290: 23/4/20: 50%->100
- 3291: 5/6/17: 0%->100 / Impacted TSs and TRs: 29.163; 29.292
- 3292: 2/3/16: 0%->100
- 3293: 5/12/16: WID:CP-160412->CP-160645
- 3294: 2/12/16: 0%->100 / Impacted TSs and TRs: 29.272; 29.273; 29.228; 29.229; 29.328; 29.329; 29.336; 29.344; 29.345; 29.128; 29.283
- 3295: 2/12/16: 0%->100 / Impacted TSs and TRs: 29.153; 29.154; 29.212; 29.214; 29.215; 29.217; 29.219; 29.213
- 3296: 2/12/16: 0%->90
- 3297: 0->5%. Mar. 15: 10%¦7/12/15: 10%->40¦13/6/16: 40%->100 / Impacted TSs and TRs: New 29.810

| ID | WBS | Task | Duration | Start | Finish | Complete | Constraint | Resources | Work | Actual work | Acronym | PCG approved | WI rapporteur e-mail | Release | TSG approved | Status Report | TSG stopped |
| --- | --- | --- | --- | --- | --- | --- | --- | --- | --- | --- | --- | --- | --- | --- | --- | --- | --- |
| 3298 | 1335 | **Diameter Base Protocol Specification Update** | 74d? | 2016-12-01 A | 2017-03-14 A | 100% |  |  | 2352h | 2352h | DBPU | 38 | Peter.Schmitt@huawei.com | Rel-14 | 74 |  |  |
| 3299 | 1335.1 | **CT aspects of Diameter Base Protocol Specification Update** | 74d? | 2016-12-01 A | 2017-03-14 A | 100% |  | ct | 1776h | 1776h | DBPU | 38 | Peter.Schmitt@huawei.com | Rel-14 | 74 |  |  |
| 3300 | 1335.1.1 | CT3 aspects of Diameter Base Protocol Specification Update | 74d? | 2016-12-01 A | 2017-03-14 A | 100% | finish no earlier than 2017-03-14 | C3 | 592h | 592h | DBPU | 38 | Peter.Schmitt@huawei.com | Rel-14 | 74 |  |  |
| 3301 | 1335.1.2 | CT4 aspects of Diameter Base Protocol Specification Update | 74d? | 2016-12-01 A | 2017-03-14 A | 100% | finish no earlier than 2017-03-14 | C4 | 592h | 592h | DBPU | 38 | Peter.Schmitt@huawei.com | Rel-14 | 74 |  |  |
| 3302 | 1335.2 | Charging aspects for Diameter Base Protocol Specification Update | 72d? | 2016-12-01 A | 2017-03-10 A | 100% | finish no earlier than 2017-03-10 | S5 | 576h | 576h | DBPU-CH | 38 | Nokia, Maryse <dot> Gardella <at> Nokia <dot> com | Rel-14 | 74 |  |  |
| 3303 | 1336 | **Enhancements to Multi-stream Multiparty Conferencing Media Handling** | 276d? | 2016-03-02 A | 2017-03-21 A | 100% |  |  | 10320h | 10320h | MMCMH_Enh | 37 | nleung@qti.qualcomm.com | Rel-14 | 72 | SP-170528 |  |
| 3304 | 1336.1 | Overall aspects of MMCMH_Enh | 196d? | 2016-06-13 A | 2017-03-10 A | 100% | finish no earlier than 2017-03-10 | S4 | 1568h | 1568h | MMCMH_Enh | 37 | nleung@qti.qualcomm.com | Rel-14 | 72 |  |  |
| 3305 | 1336.2 | **CT aspects of MMCMH_Enh** | 276d? | 2016-03-02 A | 2017-03-21 A | 100% |  | ct | 8752h | 8752h | MMCMH_Enh-CT | 37 | nevenka.biondic@ericsson.com | Rel-14 | 72 |  |  |
| 3306 | 1336.2.1 | CT1 aspects of MMCMH_Enh | 272d? | 2016-03-02 A | 2017-03-15 A | 100% | finish no earlier than 2017-03-15 | C1 | 2176h | 2176h | MMCMH_Enh-CT | 37 | nevenka.biondic@ericsson.com | Rel-14 | 72 |  |  |
| 3307 | 1336.2.2 | CT3 aspects of MMCMH_Enh | 272d? | 2016-03-02 A | 2017-03-15 A | 100% | finish no earlier than 2017-03-15 | C3 | 2176h | 2176h | MMCMH_Enh-CT | 37 | nevenka.biondic@ericsson.com | Rel-14 | 72 |  |  |
| 3308 | 1336.2.3 | CT4 aspects of MMCMH_Enh | 272d? | 2016-03-02 A | 2017-03-15 A | 100% | finish no earlier than 2017-03-15 | C4 | 2176h | 2176h | MMCMH_Enh-CT | 37 | nevenka.biondic@ericsson.com | Rel-14 | 72 |  |  |
| 3309 | 1336.2.4 | (IETF) Using Simulcast in SDP and RTP Sessions (draft-ietf-mmusic-sdp-simulcast) | 1d? | 2017-03-21 A | 2017-03-21 A | 100% | start no earlier than 2017-03-21 | C1-IETF | 8h | 8h | MMCMH_Enh-CT | 38 | tomas.frankkila@ericsson.com | Rel-14 | 75 |  |  |
| 3310 | 1336.2.5 | (IETF) RTP Payload Format Restrictions (draft-ietf-mmusic-rid) | 1d? | 2017-03-21 A | 2017-03-21 A | 100% | start no earlier than 2017-03-21 | C1-IETF | 8h | 8h | MMCMH_Enh-CT | 38 |  | Rel-14 | 75 |  |  |
| 3311 | 1337 | **Stopped - CT aspects of (or "Enhancements of") MTSI Extension on Multi-stream** | 143d? | 2016-03-02 A | 2016-09-15 A | 100% |  | ct | 4576h | 4576h | MMCMH-CT | 36 | nevenka.biondic@ericsson.com | Rel-14 | 71 |  | CP-72 |
| 3312 | 1337.1 | deleted -CT1 aspects of MTSI Extension on Multi-stream | 143d? | 2016-03-02 A | 2016-09-15 A | 100% | start no earlier than 2016-03-02 | C1 | 1144h | 1144h | MMCMH-CT | 36 | nevenka.biondic@ericsson.com | Rel-14 | 71 |  | CP-72 |
| 3313 | 1337.2 | deleted -CT3 aspects of MTSI Extension on Multi-stream | 143d? | 2016-03-02 A | 2016-09-15 A | 100% | start no earlier than 2016-03-02 | C3 | 1144h | 1144h | MMCMH-CT | 36 | nevenka.biondic@ericsson.com | Rel-14 | 71 |  | CP-72 |
| 3314 | 1337.3 | deleted -CT4 aspects of MTSI Extension on Multi-stream | 143d? | 2016-03-02 A | 2016-09-15 A | 100% | start no earlier than 2016-03-02 | C4 | 1144h | 1144h | MMCMH-CT | 36 | nevenka.biondic@ericsson.com | Rel-14 | 71 |  | CP-72 |
| 3315 | 1338 | **Control and User Plane Separation of EPC nodes** | 391d? | 2015-09-17 A | 2017-03-15 A | 100% |  |  | 5248h | 5248h | CUPS | 35 | mirko.schramm@huawei.com | Rel-14 | 69 | SP-170520 |  |
| 3316 | 1338.1 | Study on Control and User Plane Separation of EPC nodes | 197d? | 2015-09-17 A | 2016-06-17 A | 100% | finish no earlier than 2016-06-17 | S2 | 1576h | 1576h | FS_CUPS | 35 | mirko.schramm@huawei.com | Rel-14 | 69 |  |  |
| 3317 | 1338.2 | Control and User Plane Separation of EPC nodes | 72d? | 2016-06-09 A | 2016-09-15 A | 100% | finish no earlier than 2016-09-15 | S2 | 576h | 576h | CUPS | 37 | mirko.schramm@huawei.com | Rel-14 | 72 |  |  |
| 3318 | 1338.3 | **CT aspects for CUPS** | 129d? | 2016-09-16 A | 2017-03-15 A | 100% |  | ct | 3096h | 3096h | CUPS-CT | 37 | peter.schmitt@huawei.com | Rel-14 | 73 |  |  |
| 3319 | 1338.3.1 | CT3 aspects for CUPS | 129d? | 2016-09-16 A | 2017-03-15 A | 100% | finish no earlier than 2017-03-15 | C3 | 1032h | 1032h | CUPS-CT | 37 | peter.schmitt@huawei.com | Rel-14 | 73 |  |  |
| 3320 | 1338.3.2 | CT4 aspects for CUPS | 129d? | 2016-09-16 A | 2017-03-15 A | 100% | finish no earlier than 2017-03-15 | C4 | 1032h | 1032h | CUPS-CT | 37 | peter.schmitt@huawei.com | Rel-14 | 73 |  |  |
| 3321 | 1339 | **OAM14 Rel-14 Operations, Administration, Maintenance and Provisioning (OAM&P)** | 720d? | 2015-03-12 A | 2017-12-12 A | 100% |  | S5 | 35193.6h | 35193.6h | OAM14 | 35 |  | Rel-14 | 68 |  |  |
| 3322 | 1339.1 | **Management of mobile networks that include virtualized network functions** | 653d? | 2015-06-15 A | 2017-12-12 A | 100% |  | S5 | 23968h | 23968h | OAM14-MAMO_VNF | 35 | liujinglei@chinamobile.com | Rel-14 | 68 |  |  |
| 3323 | 1339.1.1 | Management concept, architecture and requirements for mobile networks that include virtualized network functions | 395d? | 2015-06-15 A | 2016-12-15 A | 100% | finish no earlier than 2016-12-15 | S5 | 3160h | 3160h | OAM14-MAMO_VNF-MCAR | 35 | liujinglei@chinamobile.com | Rel-14 | 68 |  |  |
| 3324 | 1339.1.2 | Configuration Management for mobile networks that include virtualized network functions | 454d? | 2015-09-16 A | 2017-06-09 A | 100% | finish no earlier than 2017-06-09 | S5 | 3632h | 3632h | OAM14-MAMO_VNF-CM | 35 | zhu.weihong@zte.com.cn | Rel-14 | 69 |  |  |
| 3325 | 1339.1.3 | Fault Management for mobile networks that include virtualized network functions | 454d? | 2015-09-16 A | 2017-06-09 A | 100% | finish no earlier than 2017-06-09 | S5 | 3632h | 3632h | OAM14-MAMO_VNF-FM | 35 | kai.zhangkai@huawei.com | Rel-14 | 69 |  |  |
| 3326 | 1339.1.4 | Performance management for mobile networks that include virtualized network functions | 586d? | 2015-09-16 A | 2017-12-12 A | 100% | finish no earlier than 2017-12-12 | S5 | 4688h | 4688h | OAM14-MAMO_VNF-PM | 35 | joey.chou@intel.com | Rel-14 | 69 |  |  |
| 3327 | 1339.1.5 | Lifecycle management for mobile networks that include virtualized network functions | 454d? | 2015-09-16 A | 2017-06-09 A | 100% | finish no earlier than 2017-06-09 | S5 | 3632h | 3632h | OAM14-MAMO_VNF-LCM | 35 | anatoly.andrianov@nokia.com | Rel-14 | 69 |  |  |
| 3328 | 1339.2 | Filtering of PM measurements and data volume | 199d? | 2016-03-01 A | 2016-12-01 A | 100% | start no earlier than 2016-03-01 | S5 | 1592h | 1592h | OAM14-FILMEAS | 36 | robert.petersen@ericsson.com | Rel-14 | 71 |  |  |
| 3329 | 1339.3 | Study on OAM support for Licensed Shared Access (LSA) | 262d? | 2015-03-12 A | 2016-03-11 A | 100% | finish no earlier than 2016-03-11 | S5 | 2096h | 2096h | FS_OAM_LSA | 34 | anatoly<dot>andrianov<at>nokia<dot>com | Rel-14 | 67 |  |  |
| 3330 | 1339.4 | OAM support for Licensed Shared Access (LSA) | 262d? | 2016-06-13 A | 2017-06-12 A | 100% | start no earlier than 2016-06-13 | S5 | 2096h | 2096h | OAM14-LSA | 37 |  | Rel-14 | 72 |  |  |
| 3331 | 1340 | Development of super-wideband and fullband P.835 | 524d? | 2015-06-16 A | 2017-06-15 A | 100% | finish no earlier than 2017-06-15 | S4 | 4192h | 4192h | DESUDAPS | 35 | sisabelle@audience.com | Rel-14 | 68 | SP-170346 |  |
| 3332 | 1341 | Enhancing Location Capabilities for Indoor and Outdoor Emergency Communications | 200d? | 2015-03-11 A | 2015-12-15 A | 100% | finish no earlier than 2015-12-15 | S1 | 1600h | 1600h | ELIOT | 34 | Gregory.schumacher@sprint.com | Rel-14 | 67 | SP-170553 |  |
| 3333 | 1342 | Enhancements to Domain Selection between VoLTE and CDMA CS | 69d? | 2015-03-11 A | 2015-06-15 A | 100% | finish no earlier than 2015-06-15 | S1 | 552h | 552h | eDSVCC | 34 | zhuhongmei@gsta.com | Rel-14 | 67 |  |  |
| 3334 | 1343 | Control of Applications when Third party Servers encounter difficulties | 93d? | 2015-05-11 A | 2015-09-16 A | 100% | finish no earlier than 2015-09-16 | S1 | 744h | 744h | CATS | 35 | er-yoshida (at) kddi (dot) com | Rel-14 | 68 | SP-170338 |  |

Notes:
- 3298: WI rapporteur name: Huawei, Peter Schmitt
- 3299: WI rapporteur name: Huawei, Peter Schmitt
- 3300: 6/3/17: 0%->100 / Impacted TSs and TRs: 29.061; 29.153; 29.154; 29.212; 29.214; 29.215; 29.217; 29.219; 29.368; 29.468; 29.213; 29.155; 29.201 / WI rapporteur name: Huawei, Peter Schmitt
- 3301: 2/12/16: 0%->10¦6/3/17: 10%->100 / Impacted TSs and TRs: 29.109; 29.128; 29.172; 29.173; 29.228; 29.229; 29.272; 29.273; 29.283; 29.328; 29.329; 29.336; 29.337; 29.338; 29.343; 29.344; 29.345 / WI rapporteur name: Huawei, Peter Schmitt
- 3302: 6/3/17: 0%->100 / Impacted TSs and TRs: 32.240; 32.251; 32.260; 32.270; 32.271; 32.272; 32.273; 32.274; 32.275; 32.278; 32.280; 32.295; 32.296; 32.297; 32.299 / WI rapporteur name: Nokia
- 3303: Impacted TSs and TRs: 26.114 / WI rapporteur name: Nikolai Leung
- 3304: 19/9/16: WID:SP-160272->SP-160785¦19/9/16: 0%->50¦1/12/16: 50%->80¦1/12/16: FCD:12/16->03/17¦6/3/17: 80%->100 / Impacted TSs and TRs: 26.114; 26.980 / WI rapporteur name: Nikolai Leung
- 3305: To be checked at SA4 if a part can stay in Rel-13 (now Stages 1 and 2 by SA4 in UID660050), while the CT aspects are in Rel-14. 06/16: Name changed from "CT aspects of (or "Enhancements of") MTSI Extension on Multi-stream". Acronym changed from "MMCMH- / WI rapporteur name: Ericsson, Nevenka Biondic
- 3306: Name changed from "CT1 aspects of MTSI Extension on Multi-stream". Acronym changed from "MMCMH-CT"¦13/6/16: WID:CP-160117->CP-160250. FCD: 09/16->03/17¦13/6/16: WID:CP-160250->CP-160369¦2/12/16: 0%->95¦6/3/17: 95%->100 / Impacted TSs and TRs: 24.229 / WI rapporteur name: Ericsson, Nevenka Biondic
- 3307: Acronym changed from "MMCMH-CT"¦13/6/16: WID:CP-160117->CP-160250. FCD: 09/16->03/17¦13/6/16: WID:CP-160250->CP-160369¦6/3/17: 0%->100 / Impacted TSs and TRs: 29.162; 29.213; 29.214; 29.165 / WI rapporteur name: Ericsson, Nevenka Biondic
- 3308: 3/6/16: WID:CP-160117->CP-160250. FCD: 09/16->03/17¦13/6/16: WID:CP-160250->CP-160369¦2/12/16: 0%->35¦6/3/17: 35%->75¦5/6/17: 75%->100 / Impacted TSs and TRs: 23.333; 29.333; 23.334; 29.334; 29.238 / WI rapporteur name: Ericsson, Nevenka Biondic
- 3309: 23/4/20: 50%->90; 9/4/21: RFC 8853 added; / Impacted TSs and TRs: RFC 8853 / WI rapporteur name: Ericsson
- 3310: 23/4/20: 20%->90; 9/4/21: RFC 8851 added; / Impacted TSs and TRs: RFC 8851 / WI rapporteur name: Ericsson
- 3311: Deleted, "replaced" by MMCMH_Enh-CT / WI rapporteur name: Ericsson, Nevenka Biondic
- 3312: Deleted, "replaced" by MMCMH_Enh-CT / Impacted TSs and TRs: 24.229 / WI rapporteur name: Ericsson, Nevenka Biondic
- 3313: Deleted, "replaced" by MMCMH_Enh-CT / Impacted TSs and TRs: 29.162; 29.213; 29.214; 29.165 / WI rapporteur name: Ericsson, Nevenka Biondic
- 3314: Deleted, "replaced" by MMCMH_Enh-CT / Impacted TSs and TRs: 23.333; 29.333; 23.334; 29.334; 29.238 / WI rapporteur name: Ericsson, Nevenka Biondic
- 3315: 7/12/15: 0%->20¦7/3/16: 20%->40¦9/6/16: 40%->100¦28/7/16: 23.214 added; / Impacted TSs and TRs: 23.714; 23.214 / WI rapporteur name: Huawei, Mirko Schramm
- 3316: 7/12/15: 0%->20¦7/3/16: 20%->40¦9/6/16: 40%->100 / Impacted TSs and TRs: 23.714 / WI rapporteur name: Huawei, Mirko Schramm
- 3317: 19/9/16: 0%->80¦1/12/16: 80%->100 / Impacted TSs and TRs: 23.214; 23.002; 23.203; 23.401; 23.402 / WI rapporteur name: Huawei, Mirko Schramm
- 3318: WI rapporteur name: Huawei, Peter Schmitt
- 3319: 8/6/17: 0%->100 / Impacted TSs and TRs: 29.212; 29.213 / WI rapporteur name: Huawei, Peter Schmitt
- 3320: 2/12/16: 0%->40¦6/3/17: 40%->75¦5/6/17: 75%->100 / Impacted TSs and TRs: 23.007; 29.274; 29.281; 29.303; 23.008 / WI rapporteur name: Huawei, Peter Schmitt
- 3322: June2015: WID:SP-150308->SP-150362 / WI rapporteur name: Jinglei Liu, China Mobile
- 3323: June2015: WID:SP-150309->SP-150363. Aug2015: FCD: Mar 2016¦07/09/15: 0%->20. 15/09/15: FCD: Mar 16->Dec 16, moved to Rel-14¦7/12/15: 20%->40¦7/3/16: 40%->50¦7/3/16: WID:SP-150363->SP-160023 ( FCD: Dec16->Sep16)¦13/6/16: 50%->70¦19/9/16: FCD:09/16 / Impacted TSs and TRs: 28.xyz; 32.101 / WI rapporteur name: Jinglei Liu, China Mobile (liujinglei@chinamobile.com)
- 3324: 5/10/15: 28.513¦28.512¦28.511¦28.510 added¦7/12/15: 0%->15¦7/3/16: 15%->20¦13/6/16: 20%->30¦19/9/16: 30%->50¦1/12/16: 50%->60¦1/12/16: FCD:12/16->03/17¦6/3/17: FCD:03/17->06/17¦6/3/17: 60%->80¦7/6/17: 80%->100 / Impacted TSs and TRs: 28.513; 28.512; 28.511; 28.510; 28.621; 28.622; 28.623; 28.704; 28.707 / WI rapporteur name: ZTE Corporation (Zhu Weihong, zhu.weihong@zte.com.cn)
- 3325: 5/10/15: 28.518¦28.517¦28.516¦28.515 added¦7/12/15: 0%->10¦7/3/16: 10%->15¦13/6/16: 15%->50¦13/6/16: WID:SP-150404->SP-160403¦19/9/16: 50%->75¦1/12/16: 75%->80¦1/12/16: 80%->¦1/12/16: FCD:12/16->03/17¦6/3/17: FCD:03/17->06/17¦6/3/17: 80%-> / Impacted TSs and TRs: 28.515; 28.516; 28.517; 28.518; 32.111-1; 32.111-2; 32.111-6 / WI rapporteur name: Huawei (Kai ZHANG, kai.zhangkai@huawei.com)
- 3326: 5/10/15: 28.523¦28.522¦28.521¦28.520 added¦7/12/15: 0%->10¦7/3/16: 10%->15¦13/6/16: 15%->30¦13/6/16: WID:SP-150401->SP-160402¦19/9/16: 30%->60¦1/12/16: FCD:12/16->03/17¦6/3/17: FCD:03/17->06/17¦6/3/17: 60%->75¦7/6/17: 75%->90¦7/6/17: FCD:0 / Impacted TSs and TRs: 28.523; 28.522; 28.521; 28.520; 32.426; 32.409; 32.401 / WI rapporteur name: Intel (Joey Chou, joey.chou@intel.com)
- 3327: 5/10/15: 28.528¦28.527¦28.526¦28.525 added¦7/12/15: 0%->10¦7/3/16: 10%->15¦13/6/16: 15%->25¦13/6/16: WID:SP-150403->SP-160427¦19/9/16: 25%->40¦1/12/16: 40%->60¦1/12/16: FCD:12/16->03/17¦6/3/17: FCD:03/17->06/17¦6/3/17: 60%->80¦7/6/17: 80%- / Impacted TSs and TRs: 28.525; 28.526; 28.527; 28.528; 28.704; 28.705; 28.706; 28.707; 28.708; 28.709 / WI rapporteur name: Anatoly Andrianov (anatoly.andrianov@nokia.com), Nokia Networks
- 3328: 13/6/16: 0%->15¦19/9/16: WID:SP-160022->SP-160610¦19/9/16: 15%->60¦1/12/16: 60%->95¦6/3/17: 95%->100 / Impacted TSs and TRs: New 32.817; 32.425; 32.412; 32.416; 32.130 / WI rapporteur name: Ericsson: Robert Petersen
- 3329: June2015: Compl:0%->15¦07/09/15: 15%->70¦7/12/15: 70%->75¦7/3/16: 75%->100. 22/3/16: FCD: 09/15->03/16. Rel-13->Rel-14¦28/7/16: 28.303 added¦28/7/16: 28.302 added¦28/7/16: 28.301 added¦28/7/16: 33.250 added¦28/7/16: added; / Impacted TSs and TRs: 28.303; 28.302; 28.301; / WI rapporteur name: Nokia Networks, Anatoly Andrianov
- 3330: 28/7/16: 28.303 added¦28/7/16: 28.302 added¦28/7/16: 28.301 added¦19/9/16: 0%->20¦1/12/16: 20%->30¦6/3/17: 30%->40¦7/6/17: 40%->100 / Impacted TSs and TRs: 32.101; 28.303; 28.302; 28.301 / WI rapporteur name: Nokia: Olaf Pollakowski
- 3331: 06/15: FCD corrected to Dec.15¦Aug2015: 0%->5¦07/09/15: 5%->20, FCD: 12/15->06.16¦7/12/15: 20%->40, MOVED TO REL-14¦7/3/16: 40%->50. 15/4/16: 6/16->12/16¦11/6/16: 50%->60¦19/9/16: 60%->70, fcd: 12/16->06/17¦1/12/16: 70%->75¦6/3/17: 75%->80¦7/6 / Impacted TSs and TRs: 26.131; 26.132 / WI rapporteur name: Scott Isabelle (Knowles, Inc.)
- 3332: 1/4/15: rapporteur added, Impacted TS added¦June2015: Compl:0%->25¦07/09/15: 25%->80¦2/3/16: 80%->100 / Impacted TSs and TRs: 22.101; 22.071 / WI rapporteur name: Greg Schumacher
- 3333: 1/4/15: rapporteur added, Impacted TS added¦June2015: Compl:0%->100 / Impacted TSs and TRs: 22.101 / WI rapporteur name: China Telecom, Hongmei Zhu
- 3334: 07/09/15: 0%->100 / Impacted TSs and TRs: 22.011 / WI rapporteur name: Eriko Yoshida, KDDI

| ID | WBS | Task | Duration | Start | Finish | Complete | Constraint | Resources | Work | Actual work | Acronym | PCG approved | WI rapporteur name | WI rapporteur e-mail | Release | TSG approved | Status Report |
| --- | --- | --- | --- | --- | --- | --- | --- | --- | --- | --- | --- | --- | --- | --- | --- | --- | --- |
| 3335 | 1344 | **PS Data Off Services** | 416d? | 2015-11-09 A | 2017-06-09 A | 100% |  |  | 5416h | 5416h | PS_Data_Off | 36 | Orange, Bruno Tossou | bruno.tossou@orange.com | Rel-14 | 70 | SP-170708 |
| 3336 | 1344.1 | PS Data Off Services | 92d? | 2015-11-09 A | 2016-03-15 A | 100% | finish no earlier than 2016-03-15 | S1 | 736h | 736h | PS_Data_Off | 36 | Orange, Bruno Tossou | bruno.tossou@orange.com | Rel-14 | 70 |  |
| 3337 | 1344.2 | Study on Stage 2 of PS Data off function | 131d? | 2016-06-17 A | 2016-12-15 A | 100% | finish no earlier than 2016-12-15 | S2 | 1048h | 1048h | FS_PS_DATA_OFF | 37 | Orange, david <dot> cailliere <at> orange <dot> com | david <dot> cailliere <at> orange <dot> com | Rel-14 | 72 |  |
| 3338 | 1344.3 | Stage 2 of PS Data Off | 21d? | 2016-11-17 A | 2016-12-15 A | 100% | finish no earlier than 2016-12-15 | S2 | 168h | 168h | PS_DATA_OFF | 38 | Christophe Petit (Orange) | kris (dot) petit (at) orange (dot) com | Rel-14 | 74 |  |
| 3339 | 1344.4 | **Stage 3 of PS Data Off** | 74d? | 2016-12-01 A | 2017-03-14 A | 100% |  | ct | 2368h | 2368h | PS_DATA_OFF-CT | 38 | Herrero Veron, Christian (Huawei) | Christian.Herrero at huawei.com | Rel-14 | 74 |  |
| 3340 | 1344.4.1 | CT1 aspects of PS Data Off | 74d? | 2016-12-01 A | 2017-03-14 A | 100% | finish no earlier than 2017-03-14 | C1 | 592h | 592h | PS_DATA_OFF-CT | 38 | Herrero Veron, Christian (Huawei) | Christian.Herrero at huawei.com | Rel-14 | 74 |  |
| 3341 | 1344.4.2 | CT3 aspects of PS Data Off | 74d? | 2016-12-01 A | 2017-03-14 A | 100% | finish no earlier than 2017-03-14 | C3 | 592h | 592h | PS_DATA_OFF-CT | 38 | Herrero Veron, Christian (Huawei) | Christian.Herrero at huawei.com | Rel-14 | 74 |  |
| 3342 | 1344.4.3 | CT6 aspects of PS Data Off | 74d? | 2016-12-01 A | 2017-03-14 A | 100% | finish no earlier than 2017-03-14 | C6 | 592h | 592h | PS_DATA_OFF-CT | 38 | Herrero Veron, Christian (Huawei) | Christian.Herrero at huawei.com | Rel-14 | 74 |  |
| 3343 | 1344.5 | Charging Aspect for 3GPP PS Data off Function | 137d? | 2016-12-01 A | 2017-06-09 A | 100% | finish no earlier than 2017-06-09 | S5 | 1096h | 1096h | PS_DATA_OFF-CH | 38 | Huawei， Chen, Shan | chenshan@huawei.com | Rel-14 | 74 |  |
| 3344 | 1345 | SCC AS Restoration | 208d? | 2016-03-02 A | 2016-12-15 A | 100% | finish no earlier than 2016-12-15 | C4 | 1664h | 1664h | SCCAS_RES | 36 | China Mobile, Hao Zhang, | zhanghao@chinamobile.com | Rel-14 | 71 |  |
| 3345 | 1346 | Paging Policy Enhancements and Procedure | 22d? | 2016-02-01 A | 2016-03-01 A | 100% | finish no earlier than 2016-03-01 | S1 | 176h | 176h | PPEPO_LTE | 36 | China Unicom, Zhuoyun Zhang | zhangzy910@chinaunicom.cn | Rel-14 | 71 | SP-170549 |
| 3346 | 1347 | **Enhancement to Flexible Mobile Service Steering** | 355d? | 2015-05-11 A | 2016-09-15 A | 100% |  |  | 1968h | 1968h | eFMSS | 37 | China Mobile, Lu Lu | lulu@chinamobile.com | Rel-14 | 72 |  |
| 3347 | 1347.1 | Study on enhancement to FMSS for Rel 14 | 158d? | 2015-05-11 A | 2015-12-16 A | 100% | finish no earlier than 2015-12-16 | S1 | 1264h | 1264h | FS_eFMSS | 35 | Lu Lu, China Mobile | lulu@chinamobile.com | Rel-14 | 68 |  |
| 3348 | 1347.2 | Stage 1 of Enhancement to Flexible Mobile Service Steering | 22d? | 2016-02-01 A | 2016-03-01 A | 100% | start no earlier than 2016-02-01 | S1 | 176h | 176h | eFMSS | 36 | China Mobile, Lu Lu | lulu@chinamobile.com | Rel-14 | 71 |  |
| 3349 | 1347.3 | Stage 2 of Enhancement to Flexible Mobile Service Steering | 66d? | 2016-06-17 A | 2016-09-15 A | 100% | finish no earlier than 2016-09-15 | S2 | 528h | 528h | eFMSS | 37 | ZTE, Tricci So |  | Rel-14 | 72 |  |
| 3350 | 1348 | **Media Handling Extensions of IMS-based Telepresence** | 199d? | 2016-03-01 A | 2016-12-01 A | 100% |  |  | 17512h | 17512h | IMS_TELEP_EXT | 36 | Ozgur Oyman, Intel | ozgur.oyman@intel.com | Rel-14 | 71 | SP-170515 |
| 3351 | 1348.1 | S4 aspects of Media Handling Extensions of IMS-based Telepresence | 199d? | 2016-03-01 A | 2016-12-01 A | 100% | finish no earlier than 2016-12-01 | S4 | 1592h | 1592h | IMS_TELEP_EXT | 37 | Ozgur Oyman, Intel | ozgur.oyman@intel.com | Rel-14 | 72 |  |
| 3352 | 1348.2 | **(IETF) Other IETF aspects of IMS_TELEP_EXT** | 199d? | 2016-03-01 A | 2016-12-01 A | 100% |  | S4-IETF | 15920h | 15920h | IMS_TELEP_EXT | 37 | Ozgur Oyman, Intel | ozgur.oyman@intel.com | Rel-14 | 72 |  |
| 3353 | 1348.2.1 | (IETF) RTP Payload Format for Flexible Forward Error Correction (FEC) (draft-ietf-payload-flexible-fec-scheme) --> RFC 8627 | 199d? | 2016-03-01 A | 2016-12-01 A | 100% | start no earlier than 2016-03-01 | S4-IETF | 1592h | 1592h | IMS_TELEP_EXT | 41 | Ozgur Oyman, Intel | ozgur.oyman@intel.com | Rel-14 | 80 |  |
| 3354 | 1348.2.2 | (IETF) Framework for Telepresence Multi-Streams (draft-ietf-clue-framework) | 199d? | 2016-03-01 A | 2016-12-01 A | 100% | start no earlier than 2016-03-01 | S4-IETF | 1592h | 1592h | IMS_TELEP_EXT | 41 | Ozgur Oyman, Intel | ozgur.oyman@intel.com | Rel-14 | 80 |  |
| 3355 | 1348.2.3 | (IETF) CLUE Protocol data channel (draft-ietf-clue-datachannel) | 199d? | 2016-03-01 A | 2016-12-01 A | 100% | start no earlier than 2016-03-01 | S4-IETF | 1592h | 1592h | IMS_TELEP_EXT | 41 | Ozgur Oyman, Intel | ozgur.oyman@intel.com | Rel-14 | 80 |  |
| 3356 | 1348.2.4 | (IETF) Session Signaling for Controlling Multiple Streams for Telepresence (CLUE) (draft-ietf-clue-signaling) | 199d? | 2016-03-01 A | 2016-12-01 A | 100% | start no earlier than 2016-03-01 | S4-IETF | 1592h | 1592h | IMS_TELEP_EXT | 41 | Ozgur Oyman, Intel | ozgur.oyman@intel.com | Rel-14 | 80 |  |
| 3357 | 1348.2.5 | (IETF) An XML Schema for the CLUE data model (draft-ietf-clue-data-model-schema) | 199d? | 2016-03-01 A | 2016-12-01 A | 100% | start no earlier than 2016-03-01 | S4-IETF | 1592h | 1592h | IMS_TELEP_EXT | 41 | Ozgur Oyman, Intel | ozgur.oyman@intel.com | Rel-14 | 80 |  |
| 3358 | 1348.2.6 | (IETF) Protocol for Controlling Multiple Streams for Telepresence (CLUE) (draft-ietf-clue-protocol) | 199d? | 2016-03-01 A | 2016-12-01 A | 100% | start no earlier than 2016-03-01 | S4-IETF | 1592h | 1592h | IMS_TELEP_EXT | 41 | Ozgur Oyman, Intel | ozgur.oyman@intel.com | Rel-14 | 80 |  |
| 3359 | 1348.2.7 | (IETF) Mapping RTP streams to CLUE Media Captures (draft-ietf-clue-rtp-mapping) | 199d? | 2016-03-01 A | 2016-12-01 A | 100% | start no earlier than 2016-03-01 | S4-IETF | 1592h | 1592h | IMS_TELEP_EXT | 41 | Ozgur Oyman, Intel | ozgur.oyman@intel.com | Rel-14 | 80 |  |
| 3360 | 1348.2.8 | (IETF) Session Description Protocol (SDP) Offer/Answer Procedures For Stream Control Transmission Protocol (SCTP) over Datagram Transport Layer Security (DTLS) Transport. (draft-ietf-mmusic-sctp-sdp) | 199d? | 2016-03-01 A | 2016-12-01 A | 100% | start no earlier than 2016-03-01 | S4-IETF | 1592h | 1592h | IMS_TELEP_EXT | 41 | Ozgur Oyman, Intel | ozgur.oyman@intel.com | Rel-14 | 80 |  |
| 3361 | 1348.2.9 | (IETF) SDP-based Data Channel Negotiation (draft-ietf-mmusic-data-channel-sdpneg) | 199d? | 2016-03-01 A | 2016-12-01 A | 100% | start no earlier than 2016-03-01 | S4-IETF | 1592h | 1592h | IMS_TELEP_EXT | 41 | Ozgur Oyman, Intel | ozgur.oyman@intel.com | Rel-14 | 80 |  |
| 3362 | 1349 | Improved Streaming QoE Reporting in 3GPP | 273d? | 2016-03-01 A | 2017-03-15 A | 100% | finish no earlier than 2017-03-15 | S4 | 2184h | 2184h | IQoE | 36 | Zhiming Li, Huawei | Lizhiming@huawei.com | Rel-14 | 71 | SP-170521 |
| 3363 | 1350 | New GPRS algorithms for EASE | 67d? | 2016-03-15 A | 2016-06-15 A | 100% | start no earlier than 2016-03-15 | S3 | 536h | 536h | EASE_ALGOs_SA3 | 36 | Tim Evans, Vodafone |  | Rel-14 | 71 |  |

Notes:
- 3335: 2/3/16: 0%->100 / Impacted TSs and TRs: 22.030
- 3336: 2/3/16: 0%->100 / Impacted TSs and TRs: 22.030
- 3337: 28/7/16: 23.702 added¦19/9/16: 0%->60¦1/12/16: FCD:09/16->12/16¦1/12/16: 60%->100 / Impacted TSs and TRs: 23.702
- 3338: 1/12/16: 0%->100 / Impacted TSs and TRs: 23.401; 23.203; 23.060; 23.228; 23.292; 23.221
- 3340: 6/3/17: 0%->95¦5/6/17: 95%->100 / Impacted TSs and TRs: 24.008; 24.301; 27.007; 24.229; 24.368; 24.167
- 3341: 6/3/17: 0%->60¦8/6/17: 60%->100 / Impacted TSs and TRs: 29.212; 29.213
- 3342: 7/3/17: 0%->100 / Impacted TSs and TRs: 31.102; 31.103; 31.111
- 3343: 6/3/17: 0%->70¦6/3/17: FCD:03/17->06/17¦7/6/17: 70%->100 / Impacted TSs and TRs: 32.251; 32.298; 32.299
- 3344: 13/6/16: 0%->100 / Impacted TSs and TRs: 23.380
- 3345: Impacted TSs and TRs: 22.101
- 3346: Impacted TSs and TRs: 22.115; 22.101
- 3347: 7/12/15: 70%->100 / Impacted TSs and TRs: 22.808
- 3348: Impacted TSs and TRs: 22.115; 22.101
- 3349: 19/9/16: 0%->100 / Impacted TSs and TRs: 23.203
- 3350: 11/6/16: 0%->10 / Impacted TSs and TRs: 26.223
- 3351: 11/6/16: 0%->10¦19/9/16: 10%->60¦1/12/16: 60%->100 / Impacted TSs and TRs: 26.223
- 3352: Impacted TSs and TRs: draft-ietf-payload-rtp-h265; -flexible-fec-scheme ; draft-ietf-clue-framework ; -datachannel; -signalling; -data-model-schema; -protocol; -rtp-mapping; draft-ietf-mmusic-sctp-sdp; -data-channel-sdpneg; draft-ietf-tsvwg-sctp-dtls-encaps
- 3353: 23/4/20: 25%->100
- 3354: 23/4/20: 25%->90; 9/4/21: RFC 8845 added; / Impacted TSs and TRs: RFC 8845
- 3355: 23/4/20: 25%->90; 9/4/21: RFC 8850 added; / Impacted TSs and TRs: RFC 8850
- 3356: 23/4/20: 25%->90; 9/4/21: RFC 8848 added; / Impacted TSs and TRs: RFC 8848
- 3357: 23/4/20: 25%->90; 9/4/21: RFC 8846 added; / Impacted TSs and TRs: RFC 8846
- 3358: 23/4/20: 25%->90; 9/4/21: RFC 8847 added; / Impacted TSs and TRs: RFC 8847
- 3359: 23/4/20: 25%->90; 9/4/21: RFC 8849 added; / Impacted TSs and TRs: RFC 8849
- 3360: 23/4/20: 25%->90; 9/4/21: RFC 8841 added; / Impacted TSs and TRs: RFC 8841
- 3361: 23/4/20: 25%->90; 9/4/21: RFC 8864 added; / Impacted TSs and TRs: RFC 8864
- 3362: 11/6/16: 0%->10¦19/9/16: 10%->55. FDC: 12/16->03/17¦1/12/16: 55%->65¦6/3/17: 65%->100 / Impacted TSs and TRs: New 26.909; 26.247; 26.346
- 3363: Discussion whether it should be Rel-13. To be concluded at SA#72.¦13/6/16: 0%->60¦1/12/16: 60%->70¦6/3/17: 70%->100 / Impacted TSs and TRs: 55.241; 55.242; 55.243; 55.251; 55.252; 55.253

| ID | WBS | Task | Duration | Start | Finish | Complete | Constraint | Resources | Work | Actual work | Acronym | PCG approved | Release | TSG approved | Status Report | WI rapporteur name | WI rapporteur e-mail |
| --- | --- | --- | --- | --- | --- | --- | --- | --- | --- | --- | --- | --- | --- | --- | --- | --- | --- |
| 3364 | 1351 | **S8 Home Routing Architecture for VoLTE** | 518d? | 2015-06-18 A | 2017-06-09 A | 100% |  |  | 7832h | 7832h | V8 | 36 | Rel-14 | 71 | SP-170522 |  |  |
| 3365 | 1351.1 | Study on S8 Home Routing Architecture | 191d? | 2015-06-18 A | 2016-03-10 A | 100% | finish no earlier than 2016-03-10 | S2 | 1528h | 1528h | FS_V8 | 35 | Rel-14 | 68 |  | Motohiro ABE | motohiro(dot)abe(dot)cu(at) nttdocomo (dot) com |
| 3366 | 1351.2 | Study on LI in S8 Home Routing Architecture for VoLTE | 197d? | 2015-09-17 A | 2016-06-17 A | 100% | finish no earlier than 2016-06-17 | S3 | 1576h | 1576h | FS_LIV8 | 35 | Rel-14 | 69 |  | Greg Schumacher (SPRINT) Gregory | Schumacher@sprint.com |
| 3367 | 1351.3 | S8 Home Routing Architecture for VoLTE | 135d? | 2016-06-13 A | 2016-12-15 A | 100% | finish no earlier than 2016-12-15 | S2 | 1080h | 1080h | V8 | 37 | Rel-14 | 72 |  | Motohiro ABE | motohiro(dot)abe(dot)cu(at) nttdocomo (dot) com |
| 3368 | 1351.4 | **CT Aspects of V8** | 65d? | 2016-09-16 A | 2016-12-15 A | 100% |  | ct | 1560h | 1560h | V8-CT | 37 | Rel-14 | 73 |  | Tsuyoshi Takakura (NTT DOCOMO) | tsuyoshi.takakura.ey@s1.nttdocomo.com |
| 3369 | 1351.4.1 | CT1 Aspects of V8 | 65d? | 2016-09-16 A | 2016-12-15 A | 100% | finish no earlier than 2016-12-15 | C1 | 520h | 520h | V8-CT | 37 | Rel-14 | 73 |  | Tsuyoshi Takakura (NTT DOCOMO) | tsuyoshi.takakura.ey@s1.nttdocomo.com |
| 3370 | 1351.4.2 | CT3 Aspects of V8 | 65d? | 2016-09-16 A | 2016-12-15 A | 100% | finish no earlier than 2016-12-15 | C3 | 520h | 520h | V8-CT | 37 | Rel-14 | 73 |  | Tsuyoshi Takakura (NTT DOCOMO) | tsuyoshi.takakura.ey@s1.nttdocomo.com |
| 3371 | 1351.5 | Charging Aspects of S8 Home Routing Architecture for VoLTE | 261d? | 2016-06-13 A | 2017-06-09 A | 100% | finish no earlier than 2017-06-09 | S5 | 2088h | 2088h | CH14-V8 | 37 | Rel-14 | 72 |  | Chen, Ai (China Mobile) | chenai(at) chinamobile (dot) com |
| 3372 | 1352 | **Improvements of awareness of user location change** | 453d? | 2015-09-17 A | 2017-06-09 A | 100% |  |  | 5256h | 5256h | AULC | 37 | Rel-14 | 72 | SP-170524 | Yang Xu | xuyang49@chinaunicom.cn |
| 3373 | 1352.1 | Study on improvement of awareness of user location change | 197d? | 2015-09-17 A | 2016-06-17 A | 100% | finish no earlier than 2016-06-17 | S2 | 1576h | 1576h | FS_AULC | 35 | Rel-14 | 69 |  | Yang Xu | xuyang49@chinaunicom.cn |
| 3374 | 1352.2 | Improvements of awareness of user location change | 75d? | 2016-06-06 A | 2016-09-15 A | 100% | finish no earlier than 2016-09-15 | S2 | 600h | 600h | AULC | 37 | Rel-14 | 72 |  | Yang Xu | xuyang49@chinaunicom.cn |
| 3375 | 1352.3 | **CT Aspect of AULC** | 65d? | 2016-09-16 A | 2016-12-15 A | 100% |  | ct | 1560h | 1560h | AULC-CT | 37 | Rel-14 | 73 |  | Huawei, Wu Yizhuang | wuyizhuang@huawei.com |
| 3376 | 1352.3.1 | CT3 Aspect of AULC | 65d? | 2016-09-16 A | 2016-12-15 A | 100% | finish no earlier than 2016-12-15 | C3 | 520h | 520h | AULC-CT | 37 | Rel-14 | 73 |  | Huawei, Wu Yizhuang | wuyizhuang@huawei.com |
| 3377 | 1352.3.2 | CT4 Aspect of AULC | 65d? | 2016-09-16 A | 2016-12-15 A | 100% | finish no earlier than 2016-12-15 | C4 | 520h | 520h | AULC-CT | 37 | Rel-14 | 73 |  | Huawei, Wu Yizhuang | wuyizhuang@huawei.com |
| 3378 | 1352.4 | Charging Aspects of Improvements of AULC | 190d? | 2016-09-19 A | 2017-06-09 A | 100% | finish no earlier than 2017-06-09 | S5 | 1520h | 1520h | AULC-CH | 37 | Rel-14 | 73 |  | Huawei， Chen, Shan | chenshan@huawei.com |
| 3379 | 1353 | **Service Domain Centralization** | 232d? | 2015-11-02 A | 2016-09-19 A | 100% |  | S2 | 3896h | 3896h | SeDoC | 37 | Rel-14 | 72 |  | Chris Joul (T-Mobile USA) | chris (dot) joul (at) t (dash) mobile (dot) com |
| 3380 | 1353.1 | Study on Service Domain Centralization | 230d? | 2015-11-02 A | 2016-09-15 A | 100% | finish no earlier than 2016-09-15 | S2 | 1840h | 1840h | FS_SeDoC | 36 | Rel-14 | 70 |  | Chris Joul (T-Mobile USA) | chris (dot) joul (at) t (dash) mobile (dot) com |
| 3381 | 1353.2 | Service Domain Centralization | 25d? | 2016-08-16 A | 2016-09-19 A | 100% | finish no earlier than 2016-09-19 | S2 | 200h | 200h | SeDoC | 37 | Rel-14 | 73 |  | Chris Joul (T-Mobile USA) | chris (dot) joul (at) t (dash) mobile (dot) com |
| 3382 | 1354 | **Sponsored data connectivity improvements** | 295d? | 2015-11-02 A | 2016-12-15 A | 100% |  |  | 2880h | 2880h | SDCI | 37 | Rel-14 | 72 | SP-170523 | Yang Xu | xuyang49@chinaunicom.cn |
| 3383 | 1354.1 | Study on sponsored data connectivity improvements | 160d? | 2015-11-02 A | 2016-06-10 A | 100% | finish no earlier than 2016-06-10 | S2 | 1280h | 1280h | FS_SDCI | 36 | Rel-14 | 70 |  | Yang Xu | xuyang49@chinaunicom.cn |
| 3384 | 1354.2 | Sponsored data connectivity improvements | 70d? | 2016-06-13 A | 2016-09-15 A | 100% | finish no earlier than 2016-09-15 | S2 | 560h | 560h | SDCI | 37 | Rel-14 | 72 |  | Yang Xu | xuyang49@chinaunicom.cn |
| 3385 | 1354.3 | **CT Aspects of SDCI** | 65d? | 2016-09-16 A | 2016-12-15 A | 100% |  | ct | 1040h | 1040h | SDCI-CT | 37 | Rel-14 | 73 |  | China Unicom, Xu, Yang | xuyang49@chinaunicom.cn |
| 3386 | 1354.3.1 | CT3 Aspects of SDCI | 65d? | 2016-09-16 A | 2016-12-15 A | 100% | finish no earlier than 2016-12-15 | C3 | 520h | 520h | SDCI-CT | 37 | Rel-14 | 73 |  | China Unicom, Xu, Yang | xuyang49@chinaunicom.cn |
| 3387 | 1355 | **Stage-3 SAE Protocol Development - Phase 5** | 272d? | 2016-03-02 A | 2017-03-15 A | 100% |  | C1 | 8704h | 8704h | SAES5 | 36 | Rel-14 | 71 |  | Interdigital, Aghili, Behrouz | Behrouz.aghili@interdigital.com |
| 3388 | 1355.1 | SAES5 CS Fallback in EPS | 272d? | 2016-03-02 A | 2017-03-15 A | 100% | start no earlier than 2016-03-02 | C1 | 2176h | 2176h | SAES5-CSFB | 36 | Rel-14 | 71 |  | Interdigital, Aghili, Behrouz | Behrouz.aghili@interdigital.com |
| 3389 | 1355.2 | SAES5 for support for non-3GPP accesses | 272d? | 2016-03-02 A | 2017-03-15 A | 100% | start no earlier than 2016-03-02 | C1 | 2176h | 2176h | SAES5-non3GPP | 36 | Rel-14 | 71 |  | Interdigital, Aghili, Behrouz | Behrouz.aghili@interdigital.com |
| 3390 | 1355.3 | SAE Protocol Development (Stage 3) - Phase 5 | 272d? | 2016-03-02 A | 2017-03-15 A | 100% | start no earlier than 2016-03-02 | C1 | 2176h | 2176h | SAES5 | 37 | Rel-14 | 72 |  |  |  |

Notes:
- 3364: Umbrella, created by MCC to group SA2 and SA3 activities
- 3365: 07/09/15: 0%->10¦07/09/15: 10%->100¦7/12/15: 100%->10% (mistake?) then 10%->70, FCD: 12/15-?03/16¦7/3/16: 70%->80¦9/6/16: 80%->100 / Impacted TSs and TRs: New 23.xxx
- 3366: 7/12/15: 0%->45¦28/1/16: 33.827 added¦7/3/16: 45%->55¦19/9/16: 55%->65¦15/12/17: 65%->100 / Impacted TSs and TRs: 33.827
- 3367: 11/6/16: 0%->60¦19/9/16: 60%->95¦1/12/16: FCD:09/16->12/16¦1/12/16: 95%->100 / Impacted TSs and TRs: 23.228; 23.167; 23.203
- 3369: 2/12/16: 40%->100 / Impacted TSs and TRs: 24.229
- 3370: 2/12/16: 40%->100 / Impacted TSs and TRs: 29.212; 29.213; 29.214
- 3371: 19/9/16: 0%->15¦1/12/16: FCD:12/16->03/17¦1/12/16: 15%->60¦1/12/16: WID:SP-160429->SP-160838¦6/3/17: FCD:03/17->06/17¦7/6/17: 60%->100 / Impacted TSs and TRs: 32.240; 32.251; 32.260
- 3373: 7/12/15: 0%->40¦7/3/16: 40%->70¦9/6/16: 70%->100 / Impacted TSs and TRs: 23.710
- 3374: 11/6/16: 0%->10¦19/9/16: 10%->100 / Impacted TSs and TRs: 23.401; 23.203; 23.060
- 3376: 2/12/16: 0%->10¦6/3/17: 10%->100 / Impacted TSs and TRs: 29.212; 29.213
- 3377: 2/12/16: 0%->95¦6/3/17: 95%->100 / Impacted TSs and TRs: 29.274
- 3378: 1/12/16: 0%->40¦6/3/17: 40%->80¦6/3/17: FCD:03/17->06/17¦7/6/17: 80%->100 / Impacted TSs and TRs: TS32.251; TS32.298; TS32.299
- 3380: Comes back from previous release¦28/1/16: 23.719 added¦7/3/16: 0%->30¦7/3/16: WID:SP-150626->SP-1601679/6/16: 30%->70¦11/6/16: WID:SP-160167->SP-160306. FCD: 06/16->09/16¦1/12/16: 70%->100 / Impacted TSs and TRs: 23.719
- 3381: 19/9/16: 0%->100 / Impacted TSs and TRs: 23.292; 23.167
- 3383: 28/1/16: 23.721 added¦7/3/16: 10%->40¦9/6/16: 40%->100 / Impacted TSs and TRs: 23.721
- 3384: 19/9/16: 0%->100 / Impacted TSs and TRs: 23.203; 23.682
- 3385: 6/10/16: 29.251 added; / Impacted TSs and TRs: 29.251
- 3386: 6/10/16: 29.250 added¦2/12/16: 10%->30¦6/3/17: 30%->80¦5/6/17: 80%->100 / Impacted TSs and TRs: 29.212; 29.213; 29.214; 29.201; 29.250
- 3387: Impacted TSs and TRs: 23.122; 24.008; 24.167; 24.229; 24.301; 24.302; 24.303; 24.304; 24.305; 24.312; 29.018; 29.118
- 3388: 11/6/16: 0%->5¦16/9/16: 5%->20¦2/12/16: 20%->70¦6/3/17: 70%->100 / Impacted TSs and TRs: 23.122; 24.008; 24.167; 24.229; 24.301; 24.302; 24.303; 24.304; 24.305; 24.312; 29.018; 29.118
- 3389: 11/6/16: 0%->15¦16/9/16: 15%->20¦2/12/16: 20%->85¦6/3/17: 85%->100 / Impacted TSs and TRs: 23.122; 24.008; 24.167; 24.229; 24.301; 24.302; 24.303; 24.304; 24.305; 24.312; 29.018; 29.118
- 3390: Added following CT1's chair e-mail 14/06/16¦16/9/16: 0%->20¦2/12/16: 20%->85¦6/3/17: 85%->100

| ID | WBS | Task | Duration | Start | Finish | Complete | Constraint | Resources | Work | Actual work | Acronym | PCG approved | WI rapporteur name | WI rapporteur e-mail | Release | TSG approved | Status Report |
| --- | --- | --- | --- | --- | --- | --- | --- | --- | --- | --- | --- | --- | --- | --- | --- | --- | --- |
| 3391 | 1356 | **Group based enhancements in the network capability exposure functions** | 296d? | 2015-11-02 A | 2016-12-16 A | 100% |  | S2 | 4752h | 4752h | GENCEF | 36 | Samsung, Sung Hwan Won | sunghwan.won@samsung.com | Rel-14 | 70 | SP-170517 |
| 3392 | 1356.1 | Study on group based enhancements in the network capability exposure functions | 160d? | 2015-11-02 A | 2016-06-10 A | 100% | start no earlier than 2015-11-02 | S2 | 1280h | 1280h | FS_GENCEF | 36 | Samsung, Sung Hwan Won | sunghwan.won@samsung.com | Rel-14 | 70 |  |
| 3393 | 1356.2 | Group based enhancements in the network capability exposure functions | 138d? | 2016-06-09 A | 2016-12-16 A | 100% | finish no earlier than 2016-12-16 | S2 | 1104h | 1104h | GENCEF | 37 | Samsung, Sunghoon Kim | s.hun.kim@samsung.com | Rel-14 | 72 |  |
| 3394 | 1357 | **Robust Call Setup for VoLTE subscriber in LTE** | 751d? | 2015-11-02 A | 2018-09-14 A | 100% |  |  | 11776h | 11776h | RobVoLTE | 37 |  |  | Rel-14 | 72 |  |
| 3395 | 1357.1 | Study on Robust Call Setup for VoLTE subscriber in LTE | 160d? | 2015-11-02 A | 2016-06-10 A | 100% | start no earlier than 2015-11-02 | S2 | 1280h | 1280h | FS_RobVoLTE | 36 | Xiaobo Wu, Huawei | wuxiaobo@ huawei.com | Rel-14 | 70 |  |
| 3396 | 1357.2 | Robust Call Setup for VoLTE subscriber in LTE | 66d? | 2016-06-17 A | 2016-09-15 A | 100% | finish no earlier than 2016-09-15 | S2 | 528h | 528h | RobVoLTE | 37 | Xiaobo Wu, Huawei | wuxiaobo@ huawei.com | Rel-14 | 72 |  |
| 3397 | 1357.3 | CT Aspects of RobVoLTE | 130d? | 2016-09-16 A | 2017-03-16 A | 100% | finish no earlier than 2017-03-16 | C1 | 1040h | 1040h | RobVoLTE-CT | 37 | PATEL, Milan | Milan.Patel@huawei.com | Rel-14 | 73 |  |
| 3398 | 1357.4 | **Voice and Video Enhancement for LTE** | 522d? | 2016-09-15 A | 2018-09-14 A | 100% |  | R2 | 7832h | 7832h | LTE_VoLTE_ViLTE_enh | 37 | CMCC |  | Rel-14 | 73 |  |
| 3399 | 1357.4.1 | Core part: Voice and Video Enhancement for LTE | 130d? | 2016-09-15 A | 2017-03-15 A | 100% | finish no earlier than 2017-03-15 | R2 | 1040h | 1040h | LTE_VoLTE_ViLTE_enh-Core | 37 | CMCC |  | Rel-14 | 73 | RP-170323 |
| 3400 | 1357.4.2 | UE Conformance Test Aspects –Voice and Video Enhancement for LTE | 327d? | 2017-06-15 A | 2018-09-14 A | 100% | finish no earlier than 2018-09-15 | R5 | 2616h | 2616h | LTE_VoLTE_ViLTE_enh-UEConTest | 39 | CATT |  | Rel-14 | 76 |  |
| 3401 | 1357.5 | RAN-Assisted Codec Adaptation in MTSI | 137d? | 2016-12-01 A | 2017-06-09 A | 100% | finish no earlier than 2017-06-09 | S4 | 1096h | 1096h | LTE_VoLTE_ViLTE_enh-S4 | 38 | Ozgur Oyman, Intel | ozgur.oyman@intel.com | Rel-14 | 74 | SP-170516 |
| 3402 | 1358 | Extension of UE Delay test methods and requirements | 261d? | 2016-06-13 A | 2017-06-09 A | 100% | finish no earlier than 2017-06-09 | S4 | 2088h | 2088h | EXT_UED | 37 | Stéphane Ragot, ORANGE | stephane.ragot@orange.com | Rel-14 | 72 | SP-170345 |
| 3403 | 1359 | **Improved operator control using new UE configuration parameters** | 199d? | 2016-06-13 A | 2017-03-15 A | 100% |  |  | 3184h | 3184h | IOC_UE_conf | 37 | Sedlacek, Ivo | ivo.sedlacek@ericsson.com | Rel-14 | 72 | CP-171176 |
| 3404 | 1359.1 | CT1 aspects of IOC_UE_conf | 199d? | 2016-06-13 A | 2017-03-15 A | 100% | finish no earlier than 2017-03-15 | C1 | 1592h | 1592h | IOC_UE_conf | 37 | Sedlacek, Ivo | ivo.sedlacek@ericsson.com | Rel-14 | 72 |  |
| 3405 | 1359.2 | CT6 aspects of IOC_UE_conf | 199d? | 2016-06-13 A | 2017-03-15 A | 100% | finish no earlier than 2017-03-15 | C6 | 1592h | 1592h | IOC_UE_conf | 37 | Adrian Buckley | abuckley@blackberry.com | Rel-14 | 72 |  |
| 3406 | 1360 | Shared Subscription Data Update | 135d? | 2016-06-13 A | 2016-12-15 A | 100% | finish no earlier than 2016-12-15 | C4 | 1080h | 1080h | eSDU | 37 | Nokia, Ulrich Wiehe | ulrich.wiehe@nokia.com | Rel-14 | 72 | CP-171050 |
| 3407 | 1361 | **Rel-14 Charging** | 335d? | 2016-03-01 A | 2017-06-09 A | 100% |  | S5 | 8544h | 8544h | CH14 | 36 |  |  | Rel-14 | 71 |  |
| 3408 | 1361.1 | Resource Optimization for PS Domain Online | 335d | 2016-03-01 A | 2017-06-09 A | 100% | finish no earlier than 2017-06-09 | S5 | 2680h | 2680h | CH14-ROPOCH | 36 | Shrader, David(Ericsson) | david.shrader@ericsson.com | Rel-14 | 71 |  |
| 3409 | 1361.2 | Charging for SMS via T4 | 137d? | 2016-12-01 A | 2017-06-09 A | 100% | finish no earlier than 2017-06-09 | S5 | 1096h | 1096h | CH14-SMST4 | 38 | Nokia | Maryse <dot> Gardella <at> Nokia <dot> com | Rel-14 | 74 |  |
| 3410 | 1361.3 | Charging Aspects of Enhanced Proximity-based Services | 261d? | 2016-06-13 A | 2017-06-09 A | 100% | finish no earlier than 2017-06-09 | S5 | 2088h | 2088h | CH14-ProSe | 37 | Chen, Shan | chenshan@huawei.com | Rel-14 | 72 | SP-170408 |
| 3411 | 1362 | **Determination of Completeness of Charging Information in IMS** | 261d? | 2016-06-13 A | 2017-06-09 A | 100% |  | S5 | 5952h | 5952h | CH14-DCCII | 37 | Jesske, Roland (Deutsche Telekom) |  | Rel-14 | 72 |  |
| 3412 | 1362.1 | Determination of Completeness of Charging Information in IMS | 261d? | 2016-06-13 A | 2017-06-09 A | 100% | finish no earlier than 2017-06-09 | S5 | 2088h | 2088h | CH14-DCCII | 37 | Jesske, Roland (Deutsche Telekom) |  | Rel-14 | 72 | SP-170344 |
| 3413 | 1362.2 | **CT Aspects of Determination of Completeness of Charging Information in IMS** | 74d? | 2016-12-01 A | 2017-03-14 A | 100% |  | ct | 1776h | 1776h | CH14-DCCII-CT | 38 | Michael KREIPL, Deutsche Telekom | michael(dot)kreipl(at)telekom(dot)de | Rel-14 | 74 | CP-171048 |
| 3414 | 1362.2.1 | CT1 Aspects of Determination of Completeness of Charging Information in IMS | 74d? | 2016-12-01 A | 2017-03-14 A | 100% | finish no earlier than 2017-03-14 | C1 | 592h | 592h | CH14-DCCII-CT | 38 | Michael KREIPL, Deutsche Telekom | michael(dot)kreipl(at)telekom(dot)de | Rel-14 | 74 |  |
| 3415 | 1362.2.2 | CT3 Aspects of Determination of Completeness of Charging Information in IMS | 74d? | 2016-12-01 A | 2017-03-14 A | 100% | finish no earlier than 2017-03-14 | C3 | 592h | 592h | CH14-DCCII-CT | 38 | Michael KREIPL, Deutsche Telekom | michael(dot)kreipl(at)telekom(dot)de | Rel-14 | 74 |  |

Notes:
- 3392: 28/1/16: 23.773 added¦28/1/16: 23.742 added¦7/3/16: 0%->10¦9/6/16: 10%->100 / Impacted TSs and TRs: 23.xyz; 23.773; 23.742
- 3393: 19/9/16: 0%->90¦1/12/16: FCD:09/16->12/16¦1/12/16: 90%->100 / Impacted TSs and TRs: 23.682
- 3395: 28/1/16: 23.750 added¦7/3/16: 0%->20¦9/6/16: 20%->100 / Impacted TSs and TRs: 23.8xx; 23.750
- 3396: 19/9/16: 0%->100. 1/12/16: UID changed: 720085 -> 720301 (720085 was also used for RP-161181) / Impacted TSs and TRs: 23.228; 23.237
- 3397: 2/12/16: 0%->80¦6/3/17: 80%->100 / Impacted TSs and TRs: 24.229; 24.292
- 3399: ¦20/12/16: Compl:0%->80%¦21/3/17: Compl:80%->100%¦21/3/17: Stat Rep: ->RP-170323
- 3400: ¦19/9/17: Compl:0%->20%¦8/1/18: Compl:20%->60%¦ 27/3/18: Compl:60 ;; 11/10/20: 95%->100
- 3401: 6/3/17: 0%->65¦6/3/17: FCD:03/17->06/17¦7/6/17: 65%->100
- 3402: 19/9/16: WID:SP-160271->SP-160600¦19/9/16: 0%->20¦1/12/16: 20%->30¦14/12/16: 30%->50¦6/3/17: 50%->60¦6/3/17: FCD:03/17->06/17¦7/6/17: 60%->100 / Impacted TSs and TRs: 26.954; 26.131; 26.132
- 3403: 11/6/16: 0%->10¦17/10/16: WID:CP-160296->CP-160374¦5/12/16: WID:CP-160374->CP-160828 / Impacted TSs and TRs: 24.167; 24.229; 24.301; 24.302; 24.312; 24.341; 24.368; 24.607; 24.623; 24.XXX; 24.YYY
- 3404: 11/6/16: 0%->10¦16/9/16: 10%->20¦17/10/16: WID:CP-160296->CP-160374¦2/12/16: 20%->75¦6/3/17: 75%->100 / Impacted TSs and TRs: 24.167; 24.229; 24.301; 24.302; 24.312; 24.341; 24.368; 24.607; 24.623; 24.275
- 3405: 11/6/16: 0%->10¦14/12/16: 0%->15¦7/3/17: 15%->85¦5/6/17: 85%->100 / Impacted TSs and TRs: 31.102; 31.103
- 3406: 13/6/16: 0%->25¦2/12/16: 25%->100¦5/12/16: WID:CP-160243->CP-160644 / Impacted TSs and TRs: 29.272; 29.002; 29.305; 29.230
- 3407: Umbrella Feature
- 3408: 13/6/16: 0%->10. FCD:09/16->03/17¦19/9/16: FCD: 09/16->03/17¦19/9/16: 10%->20¦1/12/16: 20%->50¦6/3/17: 50%->80¦6/3/17: FCD:03/17->06/20¦7/6/17: 80%->100 / Impacted TSs and TRs: 32.251; 32.299
- 3409: 6/3/17: 0%->20¦6/3/17: FCD:03/17->06/17¦7/6/17: 20%->100 / Impacted TSs and TRs: 32.274; 32.250 ; 32.298; 32.299
- 3410: 19/9/16: 0%->40¦1/12/16: 40%->60¦6/3/17: FCD:03/17->06/17¦6/3/17: 60%->80¦7/6/17: 80%->100 / Impacted TSs and TRs: 32.240; 32.251; 32.277; 32.298; 32.299
- 3411: 19/9/16: 0%->10 / Impacted TSs and TRs: 32.240; 32.260; 32.298; 32.299
- 3412: 19/9/16: 0%->10¦6/3/17: FCD:03/17->06/17¦7/6/17: 10%->100 / Impacted TSs and TRs: 32.240; 32.260; 32.298; 32.299
- 3414: 2/12/16: 0%->10¦6/3/17: 10%->35¦5/6/17: 35%->100 / Impacted TSs and TRs: 24.229
- 3415: 8/6/17: 0%->100 / Impacted TSs and TRs: 29.165

| ID | WBS | Task | Duration | Start | Finish | Complete | Total slack | Constraint | Resources | Work | Actual work | Acronym | PCG approved | WI rapporteur name | Release | TSG approved | Status Report | Impacted TSs and TRs |
| --- | --- | --- | --- | --- | --- | --- | --- | --- | --- | --- | --- | --- | --- | --- | --- | --- | --- | --- |
| 3416 | 1363 | **Enhanced LAA for LTE** | 720d? | 2015-12-15 A | 2018-09-14 A | 100% |  |  |  | 10480h | 10480h | LTE_eLAA | 36 | Ericsson | Rel-14 | 70 |  |  |
| 3417 | 1363.1 | Core part: Enhanced LAA for LTE | 328d? | 2015-12-15 A | 2017-03-15 A | 100% |  | finish no earlier than 2017-03-15 | R1 | 2624h | 2624h | LTE_eLAA-Core | 36 | Ericsson | Rel-14 | 70 | RP-170269 |  |
| 3418 | 1363.2 | Perf. part: Enhanced LAA for LTE | 460d? | 2015-12-15 A | 2017-09-15 A | 100% |  | finish no earlier than 2017-09-15 | R4 | 3680h | 3680h | LTE_eLAA-Perf | 36 | Ericsson | Rel-14 | 70 |  |  |
| 3419 | 1363.3 | UE Conformance Test Aspects - Enhanced LAA for LTE | 522d? | 2016-09-15 A | 2018-09-14 A | 100% |  | finish no earlier than 2018-09-15 | R5 | 4176h | 4176h | LTE_eLAA-UEConTest | 37 | Intel | Rel-14 | 73 |  |  |
| 3420 | 1364 | **RRC optimization for UMTS** | 199d? | 2015-12-15 A | 2016-09-15 A | 100% |  |  | R2 | 3184h | 3184h | UTRA_RRCopt | 36 | Ericsson | Rel-14 | 70 |  |  |
| 3421 | 1364.1 | Core part: RRC optimization for UMTS | 199d? | 2015-12-15 A | 2016-09-15 A | 100% |  | finish no earlier than 2016-09-15 | R2 | 1592h | 1592h | UTRA_RRCopt-Core | 36 | Ericsson | Rel-14 | 70 | RP-172758 |  |
| 3422 | 1365 | **DTX/DRX enhancements in CELL_FACH** | 264d? | 2015-12-15 A | 2016-12-15 A | 100% |  |  | R2 | 4224h | 4224h | FACH_DTXDRX | 36 | Huawei | Rel-14 | 70 |  |  |
| 3423 | 1365.1 | Core part: DTX/DRX enhancements in CELL_FACH | 264d? | 2015-12-15 A | 2016-12-15 A | 100% |  | finish no earlier than 2016-12-15 | R2 | 2112h | 2112h | FACH_DTXDRX-Core | 36 | Huawei | Rel-14 | 70 | RP-162132 |  |
| 3424 | 1366 | **AWS-3/4 Band for LTE** | 264d? | 2015-12-15 A | 2016-12-15 A | 100% |  |  |  | 2640h | 2640h | LTE_AWS_3_4 | 36 | Dish Network | Rel-14 | 70 |  |  |
| 3425 | 1366.1 | Core part: AWS-3/4 Band for LTE | 132d? | 2015-12-15 A | 2016-06-15 A | 100% |  | finish no earlier than 2016-09-15 | R4 | 1056h | 1056h | LTE_AWS_3_4-Core | 36 | Dish Network | Rel-14 | 70 |  | 36.749 |
| 3426 | 1366.2 | Perf. part: AWS-3/4 Band for LTE | 132d? | 2015-12-15 A | 2016-06-15 A | 100% |  | finish no earlier than 2016-09-15 | R4 | 1056h | 1056h | LTE_AWS_3_4-Perf | 36 | Dish Network | Rel-14 | 70 |  |  |
| 3427 | 1366.3 | UE Conformance Test Aspects – AWS-3/4 Band for LTE (Band 70) | 66d? | 2016-09-15 A | 2016-12-15 A | 100% |  | finish no earlier than 2017-03-15 | R5 | 528h | 528h | LTE_AWS_3_4-UEConTest | 37 | Dish Network | Rel-14 | 73 |  |  |
| 3428 | 1367 | **LTE FDD in the Bands 1980-2010 MHz and 2170-2200MHz for Region 3** | 1d? | 2015-12-15 | 2015-12-15 |  | 2670d |  | R4 | 16h |  | LTE_1980_2170_REG3 | 36 | KT Corp. | Rel-14 | 70 |  |  |
| 3429 | 1367.1 | Core part: LTE FDD in the Bands 1980-2010 MHz and 2170-2200MHz for Region 3 | 1d? | 2015-12-15 | 2015-12-15 |  | 2670d | finish no earlier than 2015-12-15 | R4 | 8h |  | LTE_1980_2170_REG3-Core | 36 | KT Corp. | Rel-14 | 70 |  |  |
| 3430 | 1368 | **Addition of 1.4 and 3 MHz Channel Bandwidth to E-UTRA operating band 65 for CGC (Complementary Ground Component) operations in Region 1** | 197d? | 2016-12-15 A | 2017-09-15 A | 100% |  |  | R4 | 2632h | 2632h | LTE_1980_2170_REG1_addBWs | 38 | Hughes Network Systems | Rel-14 | 74 |  |  |
| 3431 | 1368.1 | Core part: Addition of 1.4 and 3 MHz Channel Bandwidth to E-UTRA operating band 65 for CGC (Complementary Ground Component) operations in Region 1 | 65d? | 2016-12-15 A | 2017-03-15 A | 100% |  | finish no earlier than 2017-03-15 | R4 | 520h | 520h | LTE_1980_2170_REG1_addBWs-Core | 38 | Hughes Network Systems | Rel-14 | 74 |  |  |
| 3432 | 1368.2 | UE Conformance Test Aspects – Addition of 1.4 and 3 MHz Channel Bandwidth to E-UTRA operating band 65 for CGC (Complementary Ground Component) operations in Region 1 | 67d? | 2017-06-15 A | 2017-09-15 A | 100% |  | finish no earlier than 2017-09-15 | R5 | 536h | 536h | LTE_1980_2170_REG1_addBWs-UEConTest | 39 | Dish Network | Rel-14 | 76 |  |  |
| 3433 | 1369 | **LTE 2.6 GHz FDD Supplemental DL band (2570-2620 MHz) and LTE Carrier Aggregation (2DL/1UL) with Band 3 for region 1** | 525d? | 2015-12-15 A | 2017-12-15 A | 100% |  |  | R4 | 7896h | 7896h | LTE_FDD_2600_CA_B3 | 36 | Orange | Rel-14 | 70 |  |  |
| 3434 | 1369.1 | Core part: LTE 2.6 GHz FDD Supplemental DL band (2570-2620 MHz) and LTE Carrier Aggregation (2DL/1UL) with Band 3 for region 1 | 132d? | 2015-12-15 A | 2016-06-15 A | 100% |  | finish no earlier than 2016-09-15 | R4 | 1056h | 1056h | LTE_FDD_2600_CA_B3-Core | 36 | Orange | Rel-14 | 70 |  | 36.858 |
| 3435 | 1369.2 | Perf. part: LTE 2.6 GHz FDD Supplemental DL band (2570-2620 MHz) and LTE Carrier Aggregation (2DL/1UL) with Band 3 for region 1 | 132d? | 2015-12-15 A | 2016-06-15 A | 100% |  | finish no earlier than 2016-09-15 | R4 | 1056h | 1056h | LTE_FDD_2600_CA_B3-Perf | 36 | Orange | Rel-14 | 70 |  |  |
| 3436 | 1369.3 | UE Conformance Test Aspects - LTE 2.6 GHz FDD SDL band (2570-2620 MHz) and LTE Carrier Aggregation (2DL/1UL) with Band 3 for Region 1 (Band 69) | 198d? | 2017-03-15 A | 2017-12-15 A | 100% |  | finish no earlier than 2017-12-15 | R5 | 1584h | 1584h | LTE_FDD_2600_CA_B3-UEConTest | 38 | Bureau Veritas | Rel-14 | 75 |  |  |
| 3437 | 1370 | **Multi-Band Base Station testing with three or more bands** | 264d? | 2015-12-15 A | 2016-12-15 A | 100% |  |  | R4 | 6336h | 6336h | MB_BS_test_3B | 36 | Alcatel-Lucent | Rel-14 | 70 |  |  |
| 3438 | 1370.1 | Core part: Multi-Band Base Station testing with three or more bands | 264d? | 2015-12-15 A | 2016-12-15 A | 100% |  | finish no earlier than 2016-12-15 | R4 | 2112h | 2112h | MB_BS_test_3B-Core | 36 | Alcatel-Lucent | Rel-14 | 70 | RP-162032 | 37.871 |
| 3439 | 1370.2 | Perf. part: Multi-Band Base Station testing with three or more bands | 264d? | 2015-12-15 A | 2016-12-15 A | 100% |  | finish no earlier than 2016-12-15 | R4 | 2112h | 2112h | MB_BS_test_3B-Perf | 36 | Alcatel-Lucent | Rel-14 | 70 |  |  |

Notes:
- 3417: 22/3/16: Compl:0%->20%22/3/16: WID: RP-152272->RP-1604071/7/16: Compl:20%->60%1/7/16: WID: RP-160407->RP-160881¦26/9/16: Compl:60%->92%¦26/9/16: CD:Thu 15/09/16->Thu 15/12/16¦26/9/16: WID: ¦20/12/16: Compl:92%->97%¦20/12/16:21/3/17: Compl:
- 3418: 22/3/16: WID: RP-152272->RP-160407¦1/7/16: WID: RP-160407->RP-16088126/9/16: CD:Wed 15/03/17->Thu 15/06/1726/9/16: WID: RP-160881->RP-161832¦20/12/16: WID: RP-161832->RP-162235;21/3/17: Compl:0%->33%¦19/6/17: Compl:33%->50%¦ ;
- 3419: ¦21/3/17: Compl:0%->5% ;19/6/17: Compl:5%->6%¦19/9/17: Compl 8/1/18: C2 ;; 11/10/20: 85%->100
- 3421: 22/3/16: Compl:0%->8%¦ 1/7/16: Compl:8%->70%26/9/16: Compl:70%->100%¦8/1/18: Stat Rep: ->RP-172758
- 3423: 22/3/16: Compl:0%->20%¦1/7/16: Compl:20%->50%26/9/16: Compl:50%->65%¦20/12/16: Compl:65%->100%¦
- 3425: ¦22/3/16: Compl:0%->60%¦1/7/16: Compl:60%->100%¦1/7/16: CD:Th
- 3426: 1/7/16: Compl:0%->100%1/7/16: CD:Thu 15/09/16->Wed 15/06
- 3427: ¦20/12/16: Compl:0%->100%¦
- 3431: ¦21/3/17: Compl:0%->100% ¦2
- 3432: ¦19/9/17: Compl:0%->100%
- 3434: 28/1/16: 36.858 added;22/3/16: Compl:0%->40%22/3/16: WID: RP-152253->RP-160378¦1/7/16: Compl:40%->100%;
- 3435: ¦22/3/16: WID: RP-152253->RP-1603781/7/16: Compl:0%->100%1/7/16
- 3436: ¦19/9/17: Compl:43%->96%¦8/1/18: Compl:96%->100%¦
- 3438: 22/3/16: Compl:0%->50%22/3/16: WID: RP-152205->RP-1600631/7/16: Compl:50%->90%¦26/9/16: Compl:90%->95%¦26/9/16¦20/12/16: Compl:95%->100%¦
- 3439: 22/3/16: Compl:0%->5%22/3/16: WID: RP-152205->RP-160063¦1/7/16: Compl:5%->30%26/9/16: Compl:30%->60%26/¦20/12/16: Compl:60%->100%¦

| ID | WBS | Task | Duration | Start | Finish | Complete | Constraint | Resources | Work | Actual work | Acronym | PCG approved | WI rapporteur name | Release | TSG approved | Status Report | WI rapporteur e-mail |
| --- | --- | --- | --- | --- | --- | --- | --- | --- | --- | --- | --- | --- | --- | --- | --- | --- | --- |
| 3440 | 1371 | **Performance enhancements for high speed scenario in LTE** | 720d? | 2015-12-15 A | 2018-09-14 A | 100% |  | R4 | 14168h | 14168h | LTE_high_speed | 36 | NTT DOCOMO | Rel-14 | 70 |  |  |
| 3441 | 1371.1 | Core part: Performance enhancements for high speed scenario in LTE | 264d? | 2015-12-15 A | 2016-12-15 A | 100% | finish no earlier than 2016-12-15 | R4 | 2112h | 2112h | LTE_high_speed-Core | 36 | NTT DOCOMO | Rel-14 | 70 | RP-162222 |  |
| 3442 | 1371.2 | Perf. part: Performance enhancements for high speed scenario in LTE | 394d? | 2015-12-15 A | 2017-06-15 A | 100% | finish no earlier than 2017-06-15 | R4 | 3152h | 3152h | LTE_high_speed-Perf | 36 | NTT DOCOMO | Rel-14 | 70 |  |  |
| 3443 | 1371.3 | UE Conformance Test Aspects - Performance enhancements for high speed scenario in LTE | 393d? | 2017-03-15 A | 2018-09-14 A | 100% | finish no earlier than 2018-09-15 | R5 | 3144h | 3144h | LTE_high_speed-UEConTest | 38 | CMCC | Rel-14 | 75 |  |  |
| 3444 | 1372 | **Further Indoor Positioning Enhancements for UTRA and LTE** | 460d? | 2016-03-15 A | 2017-12-15 A | 100% |  | R2 | 9488h | 9488h | UTRA_LTE_iPos_enh2 | 36 | Huawei | Rel-14 | 71 |  |  |
| 3445 | 1372.1 | Core part: Further Indoor Positioning Enhancements for UTRA and LTE | 199d? | 2016-03-15 A | 2016-12-15 A | 100% | finish no earlier than 2016-12-15 | R2 | 1592h | 1592h | UTRA_LTE_iPos_enh2-Core | 36 | Huawei | Rel-14 | 71 | RP-162506 |  |
| 3446 | 1372.2 | Perf. part: Further Indoor Positioning Enhancements for UTRA and LTE | 329d? | 2016-03-15 A | 2017-06-15 A | 100% | finish no earlier than 2017-06-15 | R4 | 2632h | 2632h | UTRA_LTE_iPos_enh2-Perf | 36 | Huawei | Rel-14 | 71 |  |  |
| 3447 | 1372.3 | UE Conformance Test Aspects - RAT Independent Further Indoor Positioning Enhancements for LTE | 198d? | 2017-03-15 A | 2017-12-15 A | 100% | finish no earlier than 2017-12-15 | R5 | 1584h | 1584h | LTE_iPos_enh2_RI-UEConTest | 38 | NextNav | Rel-14 | 75 |  |  |
| 3448 | 1373 | **Radiated performance requirements for the verification of multi-antenna reception of UEs in LTE** | 524d? | 2016-03-15 A | 2018-03-15 A | 100% |  | R4 | 10480h | 10480h | LTE_MIMO_OTA | 36 | Intel | Rel-14 | 71 |  |  |
| 3449 | 1373.1 | Core part: Radiated performance requirements for the verification of multi-antenna reception of UEs in LTE | 395d? | 2016-03-15 A | 2017-09-15 A | 100% | finish no earlier than 2017-09-15 | R4 | 3160h | 3160h | LTE_MIMO_OTA-Core | 36 | Intel | Rel-14 | 71 |  |  |
| 3450 | 1373.2 | UE Conformance Test Aspects - Radiated Performance of Multiple-antenna Receivers in the LTE UE | 391d? | 2016-09-15 A | 2018-03-15 A | 100% | finish no earlier than 2018-03-15 | R5 | 3128h | 3128h | LTE_MIMO_OTA-UEConTest | 37 | Intel | Rel-14 | 73 |  |  |
| 3451 | 1374 | **Enhancements on Full-Dimension (FD) MIMO for LTE** | 1639d? | 2016-03-15 A | 2022-06-22 A | 100% |  | R1 | 25800h | 25800h | LTE_eFDMIMO | 36 | Samsung | Rel-14 | 71 |  |  |
| 3452 | 1374.1 | Core part: Enhancements on Full-Dimension (FD) MIMO for LTE | 263d? | 2016-03-15 A | 2017-03-15 A | 100% | finish no earlier than 2017-03-15 | R1 | 2104h | 2104h | LTE_eFDMIMO-Core | 36 | Samsung | Rel-14 | 71 | RP-170173 |  |
| 3453 | 1374.2 | Perf. part: Enhancements on Full-Dimension (FD) MIMO for LTE | 460d? | 2016-03-15 A | 2017-12-15 A | 100% | finish no earlier than 2017-12-15 | R4 | 3680h | 3680h | LTE_eFDMIMO-Perf | 36 | Samsung | Rel-14 | 71 |  |  |
| 3454 | 1374.3 | UE Conformance Test Aspects - Enhancements on Full-Dimension (FD) MIMO for LTE | 864d | 2019-03-01 A | 2022-06-22 A | 100% | finish no earlier than 2022-06-22 | R5 | 6912h | 6912h | LTE_eFDMIMO-UEConTest | 42 | Mikael ZIRÉN | Rel-14 | 83 | RP-221217 | Mikael.ziren@ericsson.com |
| 3455 | 1375 | **Further mobility enhancements in LTE** | 329d? | 2016-03-15 A | 2017-06-15 A | 100% |  | R2 | 5784h | 5784h | LTE_eMob | 36 | ZTE | Rel-14 | 71 |  |  |
| 3456 | 1375.1 | Core part: Further mobility enhancements in LTE | 263d? | 2016-03-15 A | 2017-03-15 A | 100% | finish no earlier than 2017-03-15 | R2 | 2104h | 2104h | LTE_eMob-Core | 36 | ZTE | Rel-14 | 71 | RP-170369 |  |
| 3457 | 1375.2 | Perf. Part: Further mobility enhancements in LTE | 131d? | 2016-12-15 A | 2017-06-15 A | 100% | finish no earlier than 2017-06-15 | R4 | 1048h | 1048h | LTE_eMob-Perf | 38 | ZTE | Rel-14 | 74 |  |  |
| 3458 | 1376 | **Uplink Capacity Enhancements for LTE** | 720d? | 2016-03-15 A | 2018-12-14 A | 100% |  | R1 | 13112h | 13112h | LTE_UL_CAP_enh | 36 | Ericsson | Rel-14 | 71 |  |  |
| 3459 | 1376.1 | Core part: Uplink Capacity Enhancements for LTE | 263d? | 2016-03-15 A | 2017-03-15 A | 100% | finish no earlier than 2017-03-15 | R1 | 2104h | 2104h | LTE_UL_CAP_enh-Core | 36 | Ericsson | Rel-14 | 71 | RP-170115 |  |
| 3460 | 1376.2 | Perf. part: Uplink Capacity Enhancements for LTE | 395d? | 2016-03-15 A | 2017-09-15 A | 100% | finish no earlier than 2017-09-15 | R4 | 3160h | 3160h | LTE_UL_CAP_enh-Perf | 36 | Ericsson | Rel-14 | 71 |  |  |
| 3461 | 1376.3 | UE Conformance Test Aspects - Uplink capacity enhancements for LTE | 261d? | 2017-12-15 A | 2018-12-14 A | 100% | finish no earlier than 2018-12-15 | R5 | 2088h | 2088h | LTE_UL_CAP_enh-UEConTest | 40 | Ericsson | Rel-14 | 78 |  |  |
| 3462 | 1377 | **L2 latency reduction techniques for LTE** | 524d? | 2016-03-15 A | 2018-03-15 A | 100% |  | R2 | 5784h | 5784h | LTE_LATRED_L2 | 36 | Ericsson | Rel-14 | 71 |  |  |
| 3463 | 1377.1 | Core part: L2 latency reduction techniques for LTE | 134d? | 2016-03-15 A | 2016-09-15 A | 100% | finish no earlier than 2016-09-15 | R2 | 1072h | 1072h | LTE_LATRED_L2-Core | 36 | Ericsson | Rel-14 | 71 | RP-172559 |  |
| 3464 | 1377.2 | UE Conformance Test Aspects - L2 latency reduction techniques for LTE | 65d? | 2017-12-15 A | 2018-03-15 A | 100% | finish no earlier than 2018-06-15 | R5 | 520h | 520h | LTE_LATRED_L2-UEConTest | 40 | Ericsson | Rel-14 | 78 |  |  |

Notes:
- 3441: 22/3/16: Compl:0%->5%22/3/16: WID: RP-152263->RP-160172¦1/7/16: Compl:5%->25%26/9/16: Compl:25%->45%20/12/16: Compl:45%->100%20/12/16: Stat Rep: ->RP-162222
- 3442: 22/3/16: WID: RP-152263->RP-1601721/7/16: Compl:0%->20%¦26/9/16: Compl:20%->25%¦20/12/16: Compl:25%->35% ¦21/3/17: Compl:35%->70%¦19/6/17: Compl:70%->100%¦19/6/17: WID: RP-160172->RP-171039
- 3443: tested: REL-14 LTE_high_speed-Core;¦19/6/17: Compl: 1 8/1/18:27/3/ ;; 11/10/20: 95%->100
- 3444: follow-up WI of REL-13 WI UTRA_LTE_iPos_enh
- 3445: follow-up WI of REL-13 WI UTRA_LTE_iPos_enh1/7/16: Compl:0%->30%¦26/9/16: Compl:30%->60%¦26/9/16: WID:¦20/12/16: Compl:60%->100%¦
- 3446: 26/9/16: CD:Wed 15/03/17->Thu 15/06/1726/9/16: WID: RP-160538->RP-161850¦20/12/16: Compl:0%->30%¦20/12/16: WI21/3/17: Compl:30%->50%19/6/17: Compl:50%->100%
- 3447: tested: REL-14 UTRA_LTE_iPos_enh2-Core (but only RAT independent aspects for LTE);¦ ;
- 3448: follow-up WI of REL-13 WI UTRA_LTE_MIMO_OTA-Core¦no Perf. part
- 3449: follow-up WI of REL-13 WI UTRA_LTE_MIMO_OTA-Core¦no Perf. part1/7/16: Compl:0%->10%1/7/16: WID: RP-160603->RP-16091426/9/16: Compl:10%->15%¦20/12/16: Compl:15%->25%¦20/12/16: WID: RP-160914->RP-162306;21/3/17: Compl:25%->33%;1 ;
- 3450: ¦20/12/16: Compl:0%->5%21/3/17: Compl:5%->20%19/6/17: Compl:20% 1 8/1/18: C27/3
- 3452: ¦1/7/16: Compl:0%->25%26/9/16: Compl:25%->40%¦20/12/16: Compl:40%->80%¦20/12/16: Stat Rep: -->¦21/3/17: Compl:80%->100%¦21/3/17: Stat Rep: ->RP-170173
- 3453: ¦20/12/16: Stat Rep: -->¦19/6/17: Compl:0%->50%19/9/17: Compl:50%->70%19/9/17: CD:Fri 15/09/17->Fri 15/12/17¦8/1/18: Compl:70%->100%
- 3454: 08/10/20: UID corrected (was 830185); 8/10/20: 0%->5; 8/10/20: FCD:13/09/2019->12/20; 8/4/21: FCD:11/12/2020->06/21; 2/7/21: 5%->5; 2/7/21: FCD:Fri 11/06/->12/21; 20/6/22: FCD:15/12/2021->22/06/2022; Compl:5%->100%; Stat Rep: ->RP-221217; Rapporteur: Ericsson->Mikael ZIRÉN; Rap eMail: ->Mikael.ziren@ericsson.com;
- 3455: no Perf. part
- 3456: no Perf. part¦1/7/16: Compl:0%->25%¦1/7/16: WID: RP-160636->RP-160921¦26/9/16: Compl:25%->50%¦20/12/16: Compl:50%->90%¦20/12/16: CD:Thu 15/12/16->Wed 15/03/1721/3/17: Compl:90%->100%¦21/3/17: St
- 3459: 1/7/16: Compl:0%->25%26/9/16: Compl:25%->40%¦20/12/16: Compl:40%->85%¦20/12/16: WID: RP-160664->RP-162488¦20/12/16: Stat Rep: -->21/3/17: Compl:85%->100%21/3/17: Stat Rep: ->RP-170115
- 3460: ¦20/12/16: WID: RP-160664->RP-162488¦20/12/16: Stat Rep: -->;21/3/17: Compl:0%->20%19/6/17: Compl:20%->75%¦19/9/17: Compl:75%->100%
- 3461: tested: REL-14 WI LTE_UL_CAP_enh-Core¦related to UL 256 QAM27/3 ;¦26/3/19: 35%->100
- 3462: no Perf. part¦follow-up WI of SI FS_LTE_LATRED
- 3463: no Perf. part¦follow-up WI of SI FS_LTE_LATRED¦1/7/16: Compl:0%->80%¦26/9/16: Compl:80%->100%8/1/18: Stat Rep: -->RP-172559
- 3464: tested: REL-14 WI LTE_LATRED_L2-Core27/3/18: Compl:0%->100%;

| ID | WBS | Task | Duration | Start | Finish | Complete | Remaining | Total slack | Constraint | Resources | Work | Actual work | Acronym | PCG approved | WI rapporteur name | Release | TSG approved | Status Report | WI rapporteur e-mail |
| --- | --- | --- | --- | --- | --- | --- | --- | --- | --- | --- | --- | --- | --- | --- | --- | --- | --- | --- | --- |
| 3465 | 1378 | **eMBMS enhancements for LTE** | 395d? | 2016-03-15 A | 2017-09-15 A | 100% |  |  |  | R1 | 9480h | 9480h | MBMS_LTE_enh2 | 36 | Ericsson | Rel-14 | 71 | RP-171628 |  |
| 3466 | 1378.1 | Core part: eMBMS enhancements for LTE | 395d? | 2016-03-15 A | 2017-09-15 A | 100% |  |  | finish no earlier than 2017-09-15 | R1 | 3160h | 3160h | MBMS_LTE_enh2-Core | 36 | Ericsson | Rel-14 | 71 |  |  |
| 3467 | 1378.2 | Perf. part: eMBMS enhancements for LTE | 395d? | 2016-03-15 A | 2017-09-15 A | 100% |  |  | finish no earlier than 2017-09-15 | R4 | 3160h | 3160h | MBMS_LTE_enh2-Perf | 36 | Ericsson | Rel-14 | 71 |  |  |
| 3468 | 1379 | **SRS (sounding reference signal) switching between LTE component carriers** | 590d? | 2016-03-15 A | 2018-06-15 A | 100% |  |  |  | R1 | 11568h | 11568h | LTE_SRS_switch | 36 | Huawei | Rel-14 | 71 |  |  |
| 3469 | 1379.1 | Core part: SRS (sounding reference signal) switching between LTE component carriers | 199d? | 2016-03-15 A | 2016-12-15 A | 100% |  |  | finish no earlier than 2016-12-15 | R1 | 1592h | 1592h | LTE_SRS_switch-Core | 36 | Huawei | Rel-14 | 71 | RP-162137 |  |
| 3470 | 1379.2 | Perf. part: SRS (sounding reference signal) switching between LTE component carriers | 329d? | 2016-03-15 A | 2017-06-15 A | 100% |  |  | finish no earlier than 2017-06-15 | R4 | 2632h | 2632h | LTE_SRS_switch-Perf | 36 | Huawei | Rel-14 | 71 |  |  |
| 3471 | 1379.3 | UE Conformance Test Aspects - SRS (sounding reference signal) switching between LTE component carriers | 328d? | 2017-03-15 A | 2018-06-15 A | 100% |  |  | finish no earlier than 2018-06-15 | R5 | 2624h | 2624h | LTE_SRS_switch-UEConTest | 38 | Huawei | Rel-14 | 75 |  |  |
| 3472 | 1380 | **Downlink Multiuser Superposition Transmission for LTE** | 329d? | 2016-03-15 A | 2017-06-15 A | 100% |  |  |  | R1 | 6856h | 6856h | LTE_MUST | 36 | MediaTek | Rel-14 | 71 |  |  |
| 3473 | 1380.1 | Core part: Downlink Multiuser Superposition Transmission for LTE | 199d? | 2016-03-15 A | 2016-12-15 A | 100% |  |  | finish no earlier than 2016-12-15 | R1 | 1592h | 1592h | LTE_MUST-Core | 36 | MediaTek | Rel-14 | 71 | RP-162504 |  |
| 3474 | 1380.2 | Perf. part: Downlink Multiuser Superposition Transmission for LTE | 329d? | 2016-03-15 A | 2017-06-15 A | 100% |  |  | finish no earlier than 2017-06-15 | R4 | 2632h | 2632h | LTE_MUST-Perf | 36 | MediaTek | Rel-14 | 71 |  |  |
| 3475 | 1381 | **IMS Stage-3 IETF Protocol Alignment** | 198d? | 2016-06-14 A | 2017-03-15 | 98% | 4.95d? | 2343d |  | C1 | 7920h | 6729.34h | IMSProtoc8 | 37 |  | Rel-14 | 72 |  |  |
| 3476 | 1381.1 | CT1 aspects of IMS Stage-3 IETF Protocol Alignment | 198d? | 2016-06-14 A | 2017-03-15 A | 100% |  |  | finish no earlier than 2017-03-15 | C1 | 1584h | 1584h | IMSProtoc8 | 37 | Alcatel-Lucent | Rel-14 | 72 |  | Keith Drage |
| 3477 | 1381.2 | (IETF) CT1 aspects of IMS Stage-3 IETF Protocol Alignment | 198d? | 2016-06-14 A | 2017-03-15 A | 100% |  |  | start no earlier than 2016-06-14 | C1-IETF | 1584h | 1584h | IMSProtoc8 | 37 | Alcatel-Lucent | Rel-14 | 72 |  | Keith Drage |
| 3478 | 1381.3 | (IETF) Session Description Protocol (SDP) Offer/Answer Considerations for Datagram Transport Layer Security (DTLS) and Transport Layer Security (TLS) (draft-ietf-mmusic-dtls-sdp) | 198d? | 2016-06-14 A | 2017-03-15 | 90% | 19.8d? | 2343d | start no earlier than 2016-06-14 | C1-IETF | 1584h | 396h | IMSProtoc8 | 41 | Alcatel-Lucent | Rel-14 | 80 |  | Keith Drage |
| 3479 | 1381.4 | CT3 aspects of IMS Stage-3 IETF Protocol Alignment | 198d? | 2016-06-14 A | 2017-03-15 A | 100% |  |  | start no earlier than 2016-06-14 | C3 | 1584h | 1584h | IMSProtoc8 | 37 | Alcatel-Lucent | Rel-14 | 72 |  | Keith Drage |
| 3480 | 1382 | **Multi-Carrier Enhancements for UMTS** | 264d? | 2015-12-15 A | 2016-12-15 A | 100% |  |  |  | R2 | 4232h | 4232h | UTRA_MCe | 37 | Huawei, HiSilicon | Rel-14 | 72 |  |  |
| 3481 | 1382.1 | Study on Multi-Carrier Enhancements for UMTS | 132d? | 2015-12-15 A | 2016-06-15 A | 100% |  |  | finish no earlier than 2016-06-15 | R1 | 1056h | 1056h | FS_UTRA_MCe | 36 | Huawei | Rel-14 | 70 |  |  |
| 3482 | 1382.2 | Core part: Multi-Carrier Enhancements for UMTS | 133d? | 2016-06-15 A | 2016-12-15 A | 100% |  |  | finish no earlier than 2016-12-15 | R2 | 1064h | 1064h | UTRA_MCe-Core | 37 | Huawei, HiSilicon | Rel-14 | 72 | RP-162129 |  |
| 3483 | 1383 | **Citizens Broadband Radio Service (CBRS) 3.5GHz band for LTE in the United States** | 263d? | 2016-06-15 A | 2017-06-15 A | 100% |  |  |  | R4 | 5280h | 5280h | LTE_TDD_3550_CBRS_US | 37 | Nokia | Rel-14 | 72 |  |  |
| 3484 | 1383.1 | Core part: Citizens Broadband Radio Service (CBRS) 3.5GHz band for LTE in the United States | 133d? | 2016-06-15 A | 2016-12-15 A | 100% |  |  | finish no earlier than 2016-12-15 | R4 | 1064h | 1064h | LTE_TDD_3550_CBRS_US-Core | 37 | Nokia | Rel-14 | 72 |  |  |
| 3485 | 1383.2 | Perf. part: Citizens Broadband Radio Service (CBRS) 3.5GHz band for LTE in the United States | 133d? | 2016-06-15 A | 2016-12-15 A | 100% |  |  | finish no earlier than 2016-12-15 | R4 | 1064h | 1064h | LTE_TDD_3550_CBRS_US-Perf | 37 | Nokia | Rel-14 | 72 |  |  |
| 3486 | 1383.3 | UE Conformance Test Aspects – Citizens Broadband Radio Service (CBRS) 3.5GHz Band for LTE in the United States (Band 48) | 131d? | 2016-12-15 A | 2017-06-15 A | 100% |  |  | finish no earlier than 2017-06-15 | R5 | 1048h | 1048h | LTE_TDD_3550_CBRS_US-UEConTest | 38 | Nokia | Rel-14 | 74 |  |  |
| 3487 | 1384 | **LTE Band 41 UE power class 2 operation** | 197d? | 2016-06-15 A | 2017-03-15 A | 100% |  |  |  | R4 | 4744h | 4744h | LTE_B41_UE_PC2 | 37 | Sprint | Rel-14 | 72 |  |  |
| 3488 | 1384.1 | Core part: LTE Band 41 UE power class 2 operation | 133d? | 2016-06-15 A | 2016-12-15 A | 100% |  |  | finish no earlier than 2016-12-15 | R4 | 1064h | 1064h | LTE_B41_UE_PC2-Core | 37 | Sprint | Rel-14 | 72 |  |  |
| 3489 | 1384.2 | Perf. part: LTE Band 41 UE power class 2 operation | 133d? | 2016-06-15 A | 2016-12-15 A | 100% |  |  | finish no earlier than 2016-12-15 | R4 | 1064h | 1064h | LTE_B41_UE_PC2-Perf | 37 | Sprint | Rel-14 | 72 |  |  |
| 3490 | 1384.3 | UE Conformance Test Aspects – LTE Band 41 UE power class 2 operation | 130d? | 2016-09-15 A | 2017-03-15 A | 100% |  |  | finish no earlier than 2017-03-15 | R5 | 1040h | 1040h | LTE_B41_UE_PC2-UEConTest | 37 | Sprint | Rel-14 | 73 |  |  |

Notes:
- 3466: 1/7/16: Compl:0%->10%1/7/16: CD:Tue 15/03/16->Wed 15/03/171/7/16: WID: RP-160675->RP-16129726/9/16: Compl:10%->55%¦20/12/16: Compl:55%->80%¦20/12/16: WID: RP-161297->RP-162231 ¦21/3/17: Compl:80%->90% ¦19/6/17: Compl:90 ;
- 3467: ¦1/7/16: CD:Wed 15/06/16->Fri 15/09/17¦1/7/16: WID: RP-160675->RP-161297¦20/12/16: WID: RP-161297->RP-162231¦20/12/16: Stat Rep: --> ¦21/3/17: WID: RP-162231->RP-17019919/6/17: Compl:0%->70%¦19/9/17: Compl:70%->100%
- 3469: 1/7/16: Compl:0%->35%1/7/16: WID: RP-160676->RP-160935¦26/9/16: Compl:35%->55%¦20/12/16: Compl:55%->100%¦20/12/16: Stat Rep: -->RP-162137
- 3470: 1/7/16: WID: RP-160676->RP-160935¦20/12/16: Stat Rep: --> 21/3/17: Compl:0%->25% 21/3/17: CD:Wed 15/03/17->Thu 15/06/17¦19/6/17: Compl:25%->100%
- 3471: tested: REL-14 LTE_SRS_switch-Core;¦19/6/17: Compl:0%->5%¦8/1/18: Compl:27/3/ ;
- 3473: ¦1/7/16: Compl:0%->40%¦1/7/16: WID: RP-160680->RP-16101926/9/16: Compl:40%->60%¦20/12/16: Compl:60%->100%¦20/12/16: Stat Rep: -->RP-162504
- 3474: 1/7/16: WID: RP-160680->RP-161019¦26/9/16: CD:Fri 15/09/17->Thu 15/06/17¦20/12/16: Stat Rep: --> ¦21/3/17: Compl:0%->25%19/6/17: Compl:25%->100%
- 3475: 11/6/16: 0%->15¦5/6/17: 67%->100
- 3476: Mar.15: 0->10%¦June2015: Compl:10%->30¦07/09/15: 30%->70¦7/12/15: 70%->100¦16/9/16: 0%->30¦2/12/16: 30%->75¦6/3/17: 75%->100
- 3477: Impacted TSs and TRs: draft-ietf-mmusic-dtls-sdp; draft-ietf-mmusic-4572-update (became RFC 8122)
- 3478: 23/4/20: 25%->90; 9/4/21: RFC 8842 added; / Impacted TSs and TRs: RFC 8842
- 3479: 2/4/15: added, following CT3 chair's info that the WID also has a CT3 part¦June2015: Compl:0%->20¦07/09/15: 20%->40¦7/12/15: 40%->100¦20/9/16: 0%->10¦2/12/16: 10%->30¦6/3/17: 30%->100
- 3480: no Perf. part¦follow-up WI of REL-14 SI FS_UTRA_MCe
- 3481: 22/3/16: Compl:0%->20%¦1/7/16: Compl:20%->100%¦28/7/16: 25.707 added; / Impacted TSs and TRs: 25.707
- 3482: no Perf. part¦follow-up WI of REL-14 SI FS_UTRA_MCe¦26/9/16: Compl:0%->35%¦20/12/16: Compl:35%->100%;
- 3484: 26/9/16: Compl:0%->70%¦6/10/16: 36.744 added¦20/12/16: Compl:70%->100%¦ / Impacted TSs and TRs: 36.744
- 3485: ¦20/12/16: Compl:0%->100%¦
- 3486: 21/3/17: Compl:0%->60% ¦ 19/6/17: Compl:60%->100%
- 3487: follow-up WI of SI FS_LTE_B41_HPUE
- 3488: follow-up WI of SI FS_LTE_B41_HPUE¦26/9/16: Compl:0%->80%¦20/12/16: Compl:80%->100%
- 3489: 26/9/16: Compl:0%->80%¦20/12/16: Compl:80%->100%
- 3490: ¦20/12/16: Compl:0%->65% 21/3/17: Compl:65%->100%

| ID | WBS | Task | Duration | Start | Finish | Complete | Constraint | Resources | Work | Actual work | Acronym | PCG approved | WI rapporteur name | Release | TSG approved | Status Report | Impacted TSs and TRs | WI rapporteur e-mail |
| --- | --- | --- | --- | --- | --- | --- | --- | --- | --- | --- | --- | --- | --- | --- | --- | --- | --- | --- |
| 3491 | 1385 | **Dedicated Core Networks for GERAN** | 68d? | 2016-06-15 A | 2016-09-15 A | 100% |  | R6 | 1088h | 1088h | DECOR_GERAN | 37 | Ericsson | Rel-14 | 72 |  |  |  |
| 3492 | 1385.1 | Core part: Dedicated Core Networks for GERAN | 68d? | 2016-06-15 A | 2016-09-15 A | 100% | finish no earlier than 2016-12-15 | R6 | 544h | 544h | DECOR_GERAN-Core | 37 | Ericsson | Rel-14 | 72 | RP-170194 |  |  |
| 3493 | 1386 | **Positioning Enhancements for GERAN** | 263d? | 2016-06-15 A | 2017-06-15 A | 100% |  | R6 | 6312h | 6312h | ePOS_GERAN | 37 | Ericsson | Rel-14 | 72 |  |  |  |
| 3494 | 1386.1 | Core part: Positioning Enhancements for GERAN | 263d? | 2016-06-15 A | 2017-06-15 A | 100% | finish no earlier than 2017-06-15 | R6 | 2104h | 2104h | ePOS_GERAN-Core | 37 | Ericsson | Rel-14 | 72 | RP-170920 |  |  |
| 3495 | 1386.2 | Perf. part: Positioning Enhancements for GERAN | 263d? | 2016-06-15 A | 2017-06-15 A | 100% | finish no earlier than 2017-06-15 | R6 | 2104h | 2104h | ePOS_GERAN-Perf | 37 | Ericsson | Rel-14 | 72 |  |  |  |
| 3496 | 1387 | **Quality of Experience (QoE) Measurement Collection for streaming services in UTRAN** | 858d? | 2014-12-03 A | 2018-03-15 A | 100% |  | R2 | 12664h | 12664h | UMTS_QMC_Streaming | 37 | China Unicom | Rel-14 | 73 |  |  |  |
| 3497 | 1387.1 | Study on KQIs for Service Experience | 333d? | 2014-12-03 A | 2016-03-11 A | 100% | finish no earlier than 2016-03-11 | S5 | 2664h | 2664h | FS_KQISE | 34 | Li, Hui (hui.li(at)huawei.com) | Rel-14 | 66 |  | 32.8xy | hui.li(at)huawei.com |
| 3498 | 1387.2 | Core part:Quality of Experience (QoE) Measurement Collection for streaming services in UTRAN | 130d? | 2016-09-15 A | 2017-03-15 A | 100% | finish no earlier than 2017-03-15 | R2 | 1040h | 1040h | UMTS_QMC_Streaming-Core | 37 | China Unicom | Rel-14 | 73 | RP-170259 |  |  |
| 3499 | 1387.3 | UE Conformance Test Aspects -Quality of Experience (QoE) Measurement Collection for streaming services in UTRAN | 262d? | 2017-03-15 A | 2018-03-15 A | 100% | finish no earlier than 2018-03-15 | R5 | 2096h | 2096h | UMTS_QMC_Streaming-UEConTest | 38 | Huawei | Rel-14 | 75 |  |  |  |
| 3500 | 1388 | **Flexible eNB-ID and Cell-ID in E-UTRAN** | 263d? | 2016-03-15 A | 2017-03-15 A | 100% |  | R3 | 4216h | 4216h | LTE_FNBID | 37 | China Telecom | Rel-14 | 73 |  |  |  |
| 3501 | 1388.1 | Study on flexible eNB-ID and Cell-ID in E-UTRAN | 134d? | 2016-03-15 A | 2016-09-15 A | 100% | finish no earlier than 2016-09-15 | R3 | 1072h | 1072h | FS_LTE_FNBID | 36 | China Telecom | Rel-14 | 71 |  | New 36.896 |  |
| 3502 | 1388.2 | Core part: Flexible eNB-ID and Cell-ID in E-UTRAN | 130d? | 2016-09-15 A | 2017-03-15 A | 100% | finish no earlier than 2017-03-15 | R3 | 1040h | 1040h | LTE_FNBID-Core | 37 | China Telecom | Rel-14 | 73 | RP-170478 |  |  |
| 3503 | 1389 | **4 receiver (4Rx) antenna ports with Carrier Aggregation (CA) for LTE downlink (DL)** | 522d? | 2016-09-15 A | 2018-09-14 A | 100% |  | R4 | 14648h | 14648h | LTE_4Rx_AP_DL_CA | 37 | Ericsson | Rel-14 | 73 |  |  |  |
| 3504 | 1389.1 | Core part: 4 receiver (RX) antenna ports with Carrier Aggregation (CA) for LTE downlink (DL) | 66d? | 2016-09-15 A | 2016-12-15 A | 100% | finish no earlier than 2016-12-15 | R4 | 528h | 528h | LTE_4Rx_AP_DL_CA-Core | 37 | Ericsson | Rel-14 | 73 | RP-162059 |  |  |
| 3505 | 1389.2 | Perf. part: 4 receiver (RX) antenna ports with Carrier Aggregation (CA) for LTE downlink (DL) | 262d? | 2016-09-15 A | 2017-09-15 A | 100% | finish no earlier than 2017-09-15 | R4 | 2096h | 2096h | LTE_4Rx_AP_DL_CA-Perf | 37 | Ericsson | Rel-14 | 73 |  |  |  |
| 3506 | 1389.3 | **Introduction of new band support for 4Rx antenna ports for LTE** | 457d? | 2016-12-15 A | 2018-09-14 A | 100% |  | R4 | 7848h | 7848h | LTE_4Rx_AP_DL_bands | 38 | Huawei | Rel-14 | 74 |  |  |  |
| 3507 | 1389.3.1 | Core part: Introduction of new band support for 4Rx antenna ports for LTE | 131d? | 2016-12-15 A | 2017-06-15 A | 100% | finish no earlier than 2017-06-15 | R4 | 1048h | 1048h | LTE_4Rx_AP_DL_bands-Core | 38 | Huawei | Rel-14 | 74 |  |  |  |
| 3508 | 1389.3.2 | UE Conformance Test Aspects - 4 Rx antenna ports with CA for LTE DL | 393d? | 2017-03-15 A | 2018-09-14 A | 100% | finish no earlier than 2018-09-15 | R5 | 3144h | 3144h | LTE_4Rx_AP_DL_CA-UEConTest | 38 | Ericsson | Rel-14 | 75 |  |  |  |
| 3509 | 1390 | **Requirements for a new UE category with single receiver based on Category 1 for LTE** | 522d? | 2016-09-15 A | 2018-09-14 A | 100% |  | R4 | 10456h | 10456h | LTE_UE_cat_1RX | 37 | Qualcomm | Rel-14 | 73 |  |  |  |
| 3510 | 1390.1 | Core part: Requirements for a new UE category with single receiver based on Category 1 for LTE | 196d? | 2016-09-15 A | 2017-06-15 A | 100% | finish no earlier than 2017-06-15 | R4 | 1568h | 1568h | LTE_UE_cat_1RX-Core | 37 | Qualcomm | Rel-14 | 73 | RP-171317 |  |  |
| 3511 | 1390.2 | Perf. part: Requirements for a new UE category with single receiver based on Category 1 for LTE | 262d? | 2016-09-15 A | 2017-09-15 A | 100% | finish no earlier than 2017-09-15 | R4 | 2096h | 2096h | LTE_UE_cat_1RX-Perf | 37 | Qualcomm | Rel-14 | 73 |  |  |  |
| 3512 | 1390.3 | UE Conformance Test Aspects – Requirements for a new UE category 1bis with single receiver based on category 1 for LTE | 327d? | 2017-06-15 A | 2018-09-14 A | 100% | finish no earlier than 2018-09-15 | R5 | 2616h | 2616h | LTE_UE_cat_1RX-UEConTest | 39 | Qualcomm | Rel-14 | 76 |  |  |  |
| 3513 | 1391 | **Enhanced LTE WLAN Radio Level Integration with IPsec Tunnel (eLWIP)** | 130d? | 2016-09-15 A | 2017-03-15 A | 100% |  | R3 | 2080h | 2080h | LTE_WLAN_eLWIP | 37 | Nokia | Rel-14 | 73 |  |  |  |
| 3514 | 1391.1 | Core part: Enhanced LTE WLAN Radio Level Integration with IPsec Tunnel (eLWIP) | 130d? | 2016-09-15 A | 2017-03-15 A | 100% | finish no earlier than 2017-03-15 | R3 | 1040h | 1040h | LTE_WLAN_eLWIP-Core | 37 | Nokia | Rel-14 | 73 | RP-170706 |  |  |

Notes:
- 3491: no Perf. part¦DECOR was a REL-13 SA2 feature
- 3492: no Perf. part¦DECOR was a REL-13 SA2 feature¦26/9/16: Compl:0%->100%21/3/17: Stat Rep: ->RP-170194
- 3494: 26/9/16: Compl:0%->30%¦20/12/16: Compl:30%->50% 21/3/17: Compl:50%->80% ¦19/6/17: Compl:80%->100%;
- 3495: ¦20/12/16: Compl:0%->50% ¦21/3/17: Compl:50%->80%¦19/6/17: Compl:80%->100%¦
- 3497: Mar 15: 0->5%¦June2015: Compl:0%->40¦07/09/15: 40%->50¦14/09/15: WID:SP-140784->SP-150405¦7/12/15: 50%->75¦7/12/15: WID:SP-150405->SP-150676 ¦7/3/16: 75%->100. 22/3/16: FCD: 09/15->03/16. Rel-13->Rel-14
- 3498: ¦20/12/16: Compl:0%->60% ¦21/3/17: Compl:60%->100%
- 3499: tested: REL-14 UMTS_QMC_Streaming-Core;19/6/17: Comp 19/ 8/1/18: 27/3
- 3501: 1/7/16: Compl:0%->60%26/9/16: Compl:60%->100%
- 3502: ¦20/12/16: Compl:0%->80%21/3/17: Compl:80%->100%21/3/17: Stat Rep: ->RP-170478
- 3504: ¦20/12/16: Compl:0%->100%¦20/12/16: Stat Rep: ->RP-162059
- 3505: ¦20/12/16: Compl:0%->30%;21/3/17: Compl:30%->50%19/6/17: Compl:50%->90%¦19/9/17: Compl:90%->100%
- 3506: Pending acronym
- 3507: ¦21/3/17: Compl:0%->80% ¦2119/6/17: Compl:80%->100%
- 3508: tested: REL-14 LTE_4Rx_AP_DL_CA-Core¦19/6/17: C 1 8/1/18: C 27/3/ ;¦26/3/19: 90%->100
- 3510: ¦20/12/16: Compl:0%->70%¦20/12/16: CD:Thu 15/12/16->Wed 15/03/17 ¦21/3/17: Compl:70%->95% 21/3/17: CD:Wed 15/03/17->Thu 15/06/1 19/6/17: Compl:95%->100%;
- 3511: ¦20/12/16: Compl:0%->20%¦20/12/16: CD:Thu 15/06/17->Fri 15/09/17 21/3/17: Compl:20%->70% ¦21/3/17: WID: RP-162570->RP-17079119/6/17: Compl:70%->100%;
- 3512: ¦19/9/17: Compl:0%->5%¦8/1/18: Compl:5%->45%27/3/18: Compl:45%->70%;; 11/10/20: 80%->100
- 3514: ¦20/12/16: Compl:0%->60% 21/3/17: Compl:60%->100% 21/3/17: Stat Rep: ->RP-170706

| ID | WBS | Task | Duration | Start | Finish | Complete | Remaining | Baseline start | Baseline finish | Baseline duration | Total slack | Constraint | Resources | Work | Actual work | Acronym | PCG approved | WI rapporteur name | Release | TSG approved | Status Report | WI rapporteur e-mail | MCC resp | Acronym_3GU_Export | TSG stopped | Special Focus Doc |
| --- | --- | --- | --- | --- | --- | --- | --- | --- | --- | --- | --- | --- | --- | --- | --- | --- | --- | --- | --- | --- | --- | --- | --- | --- | --- | --- |
| 3515 | 1392 | **LTE Measurement Gap Enhancement** | 329d? | 2016-03-15 A | 2017-06-15 A | 100% |  |  |  |  |  |  |  | 5264h | 5264h | LTE_meas_gap_enh | 36 | Intel | Rel-14 | 71 |  |  |  |  |  |  |
| 3516 | 1392.1 | Core part: LTE Measurement Gap Enhancement | 329d? | 2016-03-15 A | 2017-06-15 A | 100% |  |  |  |  |  | finish no earlier than 2017-06-15 | R4 | 2632h | 2632h | LTE_meas_gap_enh-Core | 36 | Intel | Rel-14 | 71 | RP-171330 |  |  |  |  |  |
| 3517 | 1392.2 | Perf. part: LTE Measurement Gap Enhancement | 329d? | 2016-03-15 A | 2017-06-15 A | 100% |  |  |  |  |  | finish no earlier than 2017-06-15 | R4 | 2632h | 2632h | LTE_meas_gap_enh-Perf | 36 | Intel | Rel-14 | 71 |  |  |  |  |  |  |
| 3518 | 1393 | **Enhanced CRS and SU-MIMO Interference Mitigation Performance Requirements for LTE** | 262d? | 2016-09-15 A | 2017-09-15 A | 100% |  |  |  |  |  |  |  | 2096h | 2096h | LTE_eCRSIM_eSUMIMO | 37 | Intel | Rel-14 | 73 |  |  |  |  |  |  |
| 3519 | 1393.1 | Perf. part: Enhanced CRS and SU-MIMO Interference Mitigation Performance Requirements for LTE | 262d? | 2016-09-15 A | 2017-09-15 A | 100% |  |  |  |  |  | finish no earlier than 2017-09-15 | R4 | 2096h | 2096h | LTE_eCRSIM_eSUMIMO-Perf | 37 | Intel | Rel-14 | 73 |  |  |  |  |  |  |
| 3520 | 1394 | **Miscellaneous IETF dependencies** | 843d? | 2017-03-15 A | 2020-06-05 A | 100% |  |  |  |  |  |  |  | 5488h | 5488h | TEI14_IETF | 40 |  | Rel-14 | 78 |  |  |  |  |  |  |
| 3521 | 1394.1 | (IETF) T.140 Real-time Text Conversation over WebRTC Data Channels (draft-ietf-mmusic-t140-usage-data-channel) | 87d? | 2020-02-06 A | 2020-06-05 A | 100% |  |  |  |  |  | finish no earlier than 2020-06-06 | CT1-IETF | 696h | 696h | TEI14_IETF | 40 |  | Rel-14 | 78 |  |  |  |  |  |  |
| 3522 | 1394.2 | (IETF) SDP Offer/Answer Clarifications for RTP/RTCP Multiplexing [RFC 5761 (was draft-ietf-avtcore-5761-update)] | 133d? | 2017-03-15 A | 2017-09-15 A | 100% |  |  |  |  |  | finish no earlier than 2017-09-15 | CT1-IETF | 1064h | 1064h | TEI14_IETF | 40 |  | Rel-14 | 78 |  |  |  |  |  |  |
| 3523 | 1394.3 | (IETF) T.140 Real-time Text Conversation over WebRTC Data Channels (draft-ietf-mmusic-t140-usage-data-channel) | 197d? | 2017-03-15 A | 2017-12-14 A | 100% |  |  |  |  |  | finish no earlier than 2017-12-14 | CT1-IETF | 1576h | 1576h | TEI14_IETF | 40 |  | Rel-14 | 78 |  |  |  |  |  |  |
| 3524 | 1394.4 | (IETF) T.140 Real-time Text Conversation over WebRTC Data Channels (draft-ietf-mmusic-t140-usage-data-channel) | 197d? | 2017-03-15 A | 2017-12-14 A | 100% |  |  |  |  |  | finish no earlier than 2017-12-14 | CT1-IETF | 1576h | 1576h | TEI14_IETF | 40 |  | Rel-14 | 78 |  |  |  |  |  |  |
| 3525 | 1394.5 | (IETF) Negotiating Media Multiplexing Using the Session Description Protocol (SDP) (draft-ietf-mmusic-sdp-bundle-negotiation) | 24d | 2020-03-23 A | 2020-04-23 A | 100% |  |  |  |  |  | start no earlier than 2020-03-23 | C1-IETF | 192h | 192h | TEI14_IETF | 44 |  | Rel-14 | 87 |  |  |  |  |  |  |
| 3526 | 1394.6 | (IETF) Indicating Exclusive Support of RTP/RTCP Multiplexing using SDP (draft-ietf-mmusic-mux-exclusive) | 24d | 2020-03-23 A | 2020-04-23 A | 100% |  |  |  |  |  | start no earlier than 2020-03-23 | C1-IETF | 192h | 192h | TEI14_IETF | 44 |  | Rel-14 | 87 |  |  |  |  |  |  |
| 3527 | 1394.7 | (IETF) IP Mobility Support for IPv4, Revised (draft-ietf-mip4-rfc3344bis) --> RFC 5944 | 24d | 2020-03-23 A | 2020-04-23 A | 100% |  |  |  |  |  | start no earlier than 2020-03-23 | C1-IETF | 192h | 192h | TEI14_IETF | 44 |  | Rel-14 | 87 |  |  |  |  |  |  |
| 3528 | 1395 | **Security Assurance Specification for 3GPP network products** | 924d? | 2013-12-09 A | 2017-06-15 A | 100% |  | 2013-12-09 | 2015-03-18 | 334d? |  |  | S3 | 23192h | 23192h | SCAS | 32 | NTT DOCOMO | Rel-14 | 62 |  | Alf Zugenmaier (alf.zugenmaier@hm.edu) | Mirko | SCAS |  |  |
| 3529 | 1395.1 | STOPPED - TR on Pilot development of Security Assurance Specification for MME network product class | 266d? | 2013-12-09 A | 2014-12-12 A | 100% |  | 2013-12-09 | 2014-12-10 | 264d? |  | finish no earlier than 2014-12-12 | S3 | 2120h | 2120h | SCAS-SA3Pil_TR | 32 | NTT DOCOMO | Rel-14 | 62 |  | Alf Zugenmaier (alf.zugenmaier@hm.edu) | Mirko |  | 80 |  |
| 3530 | 1395.2 | TR on Security Assurance scheme for 3GPP network products | 791d? | 2013-12-09 A | 2016-12-15 A | 100% |  | 2013-12-09 | 2014-12-10 | 264d? |  | finish no earlier than 2016-12-15 | S3 | 6320h | 6320h | SCAS-SA3TR | 32 | NTT DOCOMO | Rel-14 | 62 |  | Alf Zugenmaier (alf.zugenmaier@hm.edu) | Mirko |  |  |  |
| 3531 | 1395.3 | Security Assurance Specification for 3GPP network product classes | 920d? | 2013-12-13 A | 2017-06-15 A | 100% |  | 2013-12-10 | 2015-03-18 | 333d? |  | finish no earlier than 2017-06-15 | S3 | 7360h | 7360h | SCAS-SA3 | 32 | China Mobile | Rel-14 | 62 |  | Judy Zhu (zhuhongru@chinamobile.com) | Mirko |  |  |  |
| 3532 | 1396 | (Small) Technical Enhancements and Improvements for Rel-14 | 29d? | 2015-05-11 A | 2015-06-18 A | 100% |  |  |  |  |  | start no earlier than 2015-05-11 | SP; CP; RP; R4 | 928h | 928h | TEI14 | 35 |  | Rel-14 | 68 |  |  |  |  |  |  |
| 3533 | 1397 | (Small) Test Technical Enhancements and Improvements for Rel-14 | 593d? | 2016-09-13 A | 2018-12-20 A | 100% |  |  |  |  |  | start no earlier than 2016-09-13 | SP; CP; RP; GP | 18976h | 18976h | TEI14_Test | 35 |  | Rel-14 | 68 |  |  |  |  |  |  |
| 3534 | 1398 | **Rel-14 LTE Carrier Aggregation** | 131d? | 2015-09-15 A | 2016-03-15 | 90% | 13.09d? | 2014-03-06 | 2015-06-12 | 332d? | 2605d |  | R4 | 9968h | 8897.13h | LTE_CA_Rel14 | 30 |  | Rel-14 | 58 |  |  | Issam | LTE_CA_Rel-13 |  | CA |
| 3535 | 1398.1 | **LTE Advanced 4 Band Carrier Aggregation (4DL/1UL) of Band 4, Band 5, Band 12 and Band 12** | 131d? | 2015-09-15 A | 2016-03-15 | 90% | 13.09d? |  |  |  | 2605d |  | R4 | 3144h | 2829.72h | LTE_CA_B4_B5_B12_B12 | PCG-35 | US Cellular | Rel-14 | RP-69 |  |  |  |  |  |  |
| 3536 | 1398.1.1 | Core part: LTE Advanced 4 Band Carrier Aggregation (4DL/1UL) of Band 4, Band 5, Band 12 and Band 12 | 131d? | 2015-09-15 A | 2016-03-15 | 90% | 13.1d? |  |  |  | 2605d | finish no earlier than 2016-03-15 | R4 | 1048h | 943.2h | LTE_CA_B4_B5_B12_B12-Core | PCG-35 | US Cellular | Rel-14 | RP-69 |  |  |  |  |  |  |
| 3537 | 1398.1.2 | Perf. part: LTE Advanced 4 Band Carrier Aggregation (4DL/1UL) of Band 4, Band 5, Band 12 and Band 12 | 131d? | 2015-09-15 A | 2016-03-15 | 90% | 13.1d? |  |  |  | 2605d | finish no earlier than 2016-03-15 | R4 | 1048h | 943.2h | LTE_CA_B4_B5_B12_B12-Perf | PCG-35 | US Cellular | Rel-14 | RP-69 |  |  |  |  |  |  |
| 3538 | 1398.2 | **LTE Advanced 4 Band Carrier Aggregation (4DL/1UL) of Band 4, Band 4, Band 12 and Band 12** | 131d? | 2015-09-15 A | 2016-03-15 | 90% | 13.09d? |  |  |  | 2605d |  | R4 | 3144h | 2829.72h | LTE_CA_B4_B4_B12_B12 | PCG-35 | US Cellular | Rel-14 | RP-69 |  |  |  |  |  |  |
| 3539 | 1398.2.1 | Core part: LTE Advanced 4 Band Carrier Aggregation (4DL/1UL) of Band 4, Band 4, Band 12 and Band 12 | 131d? | 2015-09-15 A | 2016-03-15 | 90% | 13.1d? |  |  |  | 2605d | finish no earlier than 2016-03-15 | R4 | 1048h | 943.2h | LTE_CA_B4_B4_B12_B12-Core | PCG-35 | US Cellular | Rel-14 | RP-69 |  |  |  |  |  |  |
| 3540 | 1398.2.2 | Perf. part: LTE Advanced 4 Band Carrier Aggregation (4DL/1UL) of Band 4, Band 4, Band 12 and Band 12 | 131d? | 2015-09-15 A | 2016-03-15 | 90% | 13.1d? |  |  |  | 2605d | finish no earlier than 2016-03-15 | R4 | 1048h | 943.2h | LTE_CA_B4_B4_B12_B12-Perf | PCG-35 | US Cellular | Rel-14 | RP-69 |  |  |  |  |  |  |

Notes:
- 3516: ¦1/7/16: Compl:0%->10%¦1/7/16: CD:Thu 15/06/17->Wed 15/03/17¦1/7/16: WID: RP-160678->RP-160912¦26/9/16: Compl:10%->25%26/9/16: R¦20/12/16: Compl:25%->60% 21/3/17: Compl:60%->95% 19/6/17: Compl:95%->100%
- 3517: 1/7/16: WID: RP-160678->RP-1609121/7/16: Release: Rel-15->Rel-14¦20/12/16: Stat Rep: -->¦20/12/16: Release: Rel-15->Rel-14 21/3/17: Compl:0%->20% 21/3/17: Release: Rel19/6/17: Compl:20%->100%
- 3518: Impacted TSs and TRs: 39.747
- 3519: 6/10/16: 36.176 added¦20/12/16: Compl:0%->30%21/3/17: Compl:30%->50% ¦21/3/17: Release: Rel-15->Rel-14¦19/6/17: Compl:50%->85%19/9/17: Compl:85%->100% / Impacted TSs and TRs: 36.176
- 3520: Created upon demand of RAN5
- 3521: 9/4/21: RFC 8865 added; / Impacted TSs and TRs: RFC 8865
- 3523: was (IETF) T.140 Text Conversation over Data Channels (draft-schwarz-mmusic-t140-usage-data-channel); 9/4/21: RFC 8865 added; / Impacted TSs and TRs: RFC 8865
- 3524: 22/3/18: 25%->100. was (IETF) BFCP floor control signalling over Data Channels (draft-schwarz-mmusic-bfcp-usage-data-channel). ; 9/4/21: RFC 8865 added; / Impacted TSs and TRs: RFC 8865
- 3525: 9/4/21: RFC 8843 added; / Impacted TSs and TRs: RFC 8843
- 3526: 9/4/21: RFC 8858 added; / Impacted TSs and TRs: RFC 8858
- 3528: Triggered by Rel-12 TR 33.805 Study on Security Assurance Methodology for 3GPP Network Elements (FS_SECAM)¦June2015: WID:SP-130718->SP-150292. Aug 15: TR numb added¦28/1/16: 33.926 added¦28/7/16: 33.250 added;06/10/16: moved to Rel-14 as per John/M / Impacted TSs and TRs: 33.199; 33.926; 33.117; 33.250; 33.515
- 3529: This TR collects input for the new TS 33.116. Dec.14: 55->70%. 3/3/15: 70->55%. 10/03/15: 55->75%¦June2015: Compl:75%->80¦7/12/15: STOPPED AT 80% (marked as 100% here since no more work expected) / Impacted TSs and TRs: New 33.806
- 3530: This TR contains results of the second WID objective. Dec.14: 75->85%¦June2015: Compl:85%->90¦7/12/15: 90%->92¦10/12/15: WID:SP-130718->SP-150716¦19/9/16: 92%->98. FCD set to 12.16 (was 03/16)¦6/10/16: 33.216 added¦1/12/16: 81%->100 / Impacted TSs and TRs: New 33.916; 33.216
- 3531: June2015: 0%->5¦7/12/15: 5%->72.¦10/12/15: WID:SP-130718->SP-150716¦7/3/16: 72%->75¦28/7/16: 33.250 added¦19/9/16: 75%->90. FCD set to 12.16 (was 03/16). 6/3/17: moved from Rel-14.¦15/2/18: moved back to Rel-14¦6/8/18: 33.515 added; / Impacted TSs and TRs: New 33.116; 33.117; 33.250; 22.511; 22.512; 22.513; 22.514; 33.515
- 3533: Created upon demand of RAN5
- 3534: Acronym changed from "LTE_CA_Rel-13" to "LTE_CA_Rel13"

| ID | WBS | Task | Duration | Start | Finish | Complete | Remaining | Baseline start | Baseline finish | Baseline duration | Total slack | Constraint | Resources | Work | Actual work | Acronym | PCG approved | WI rapporteur name | Release | TSG approved | MCC resp | Special Focus Doc | Acronym_3GU_Export | Impacted TSs and TRs |
| --- | --- | --- | --- | --- | --- | --- | --- | --- | --- | --- | --- | --- | --- | --- | --- | --- | --- | --- | --- | --- | --- | --- | --- | --- |
| 3541 | 1398.3 | **LTE Advanced 4 Band Carrier Aggregation (4DL/1UL) of Band 2, Band 4, Band 12 and Band 12** | 131d? | 2015-09-15 A | 2016-03-15 | 90% | 13.09d? |  |  |  | 2605d |  | R4 | 3144h | 2829.72h | LTE_CA_B2_B4_B12_B12 | PCG-35 | US Cellular | Rel-14 | RP-69 |  |  |  |  |
| 3542 | 1398.3.1 | Core part: LTE Advanced 4 Band Carrier Aggregation (4DL/1UL) of Band 2, Band 4, Band 12 and Band 12 | 131d? | 2015-09-15 A | 2016-03-15 | 90% | 13.1d? |  |  |  | 2605d | finish no earlier than 2016-03-15 | R4 | 1048h | 943.2h | LTE_CA_B2_B4_B12_B12-Core | PCG-35 | US Cellular | Rel-14 | RP-69 |  |  |  |  |
| 3543 | 1398.3.2 | Perf. part: LTE Advanced 4 Band Carrier Aggregation (4DL/1UL) of Band 2, Band 4, Band 12 and Band 12 | 131d? | 2015-09-15 A | 2016-03-15 | 90% | 13.1d? |  |  |  | 2605d | finish no earlier than 2016-03-15 | R4 | 1048h | 943.2h | LTE_CA_B2_B4_B12_B12-Perf | PCG-35 | US Cellular | Rel-14 | RP-69 |  |  |  |  |
| 3544 | 1399 | **Rel-14LTE Advanced inter-band Carrier Aggregation** | 1507d? | 2015-12-15 A | 2021-09-21 | 87% | 189.57d? | 2014-03-06 | 2015-06-12 | 332d? | 1164d |  | R4 | 96616h | 70396.3h | LTE_AIBCA_Rel14 | 30 |  | Rel-14 | 58 | Issam | CA | LTE_CA_Rel-13 |  |
| 3545 | 1399.1 | **LTE Advanced inter-band Carrier Aggregation Rel-14 for 5DL/1UL** | 394d? | 2015-12-15 A | 2017-06-15 | 95% | 19.69d? |  |  |  | 2277d |  | R4 | 9456h | 8416.04h | LTE_CA_R14_5DL1UL | PCG-36 | Nokia Networks | Rel-14 | RP-70 |  |  |  |  |
| 3546 | 1399.1.1 | Core part: LTE Advanced inter-band Carrier Aggregation Rel-14 for 5DL/1UL | 394d? | 2015-12-15 A | 2017-06-15 | 95% | 19.7d? |  |  |  | 2277d | finish no earlier than 2017-06-15 | R4 | 3152h | 2994.4h | LTE_CA_R14_5DL1UL-Core | PCG-36 | Nokia Networks | Rel-14 | RP-70 |  |  |  | 36.714-05-01 |
| 3547 | 1399.1.2 | Perf. part: LTE Advanced inter-band Carrier Aggregation Rel-14 for 5DL/1UL | 394d? | 2015-12-15 A | 2017-06-15 | 95% | 19.7d? |  |  |  | 2277d | finish no earlier than 2017-06-15 | R4 | 3152h | 2994.4h | LTE_CA_R14_5DL1UL-Perf | PCG-36 | Nokia Networks | Rel-14 | RP-70 |  |  |  |  |
| 3548 | 1399.2 | **LTE Advanced inter-band Carrier Aggregation Rel-14 for 2DL/1UL** | 394d? | 2015-12-15 A | 2017-06-15 | 80% | 78.8d? |  |  |  | 2277d |  | R4 | 9456h | 7076.85h | LTE_CA_R14_2DL1UL | PCG-36 | Qualcomm | Rel-14 | RP-70 |  |  |  |  |
| 3549 | 1399.2.1 | Core part: LTE Advanced inter-band Carrier Aggregation Rel-14 for 2DL/1UL | 394d? | 2015-12-15 A | 2017-06-15 | 80% | 78.8d? |  |  |  | 2277d | finish no earlier than 2017-06-15 | R4 | 3152h | 2521.6h | LTE_CA_R14_2DL1UL-Core | PCG-36 | Qualcomm | Rel-14 | RP-70 |  |  |  | 36.714-02-01 |
| 3550 | 1399.2.2 | Perf. part: LTE Advanced inter-band Carrier Aggregation Rel-14 for 2DL/1UL | 394d? | 2015-12-15 A | 2017-06-15 | 80% | 78.8d? |  |  |  | 2277d | finish no earlier than 2017-06-15 | R4 | 3152h | 2521.6h | LTE_CA_R14_2DL1UL-Perf | PCG-36 | Qualcomm | Rel-14 | RP-70 |  |  |  |  |
| 3551 | 1399.3 | **LTE Advanced inter-band Carrier Aggregation Rel-14 for 2DL/2UL** | 394d? | 2015-12-15 A | 2017-06-15 | 90% | 39.4d? |  |  |  | 2277d |  | R4 | 9456h | 7904.07h | LTE_CA_R14_2DL2UL | PCG-36 | Huawei | Rel-14 | RP-70 |  |  |  |  |
| 3552 | 1399.3.1 | Core part: LTE Advanced inter-band Carrier Aggregation Rel-14 for 2DL/2UL | 394d? | 2015-12-15 A | 2017-06-15 | 90% | 39.4d? |  |  |  | 2277d | finish no earlier than 2017-06-15 | R4 | 3152h | 2836.8h | LTE_CA_R14_2DL2UL-Core | PCG-36 | Huawei | Rel-14 | RP-70 |  |  |  | 36.714-02-02 |
| 3553 | 1399.3.2 | Perf. part: LTE Advanced inter-band Carrier Aggregation Rel-14 for 2DL/2UL | 394d? | 2015-12-15 A | 2017-06-15 | 90% | 39.4d? |  |  |  | 2277d | finish no earlier than 2017-06-15 | R4 | 3152h | 2836.8h | LTE_CA_R14_2DL2UL-Perf | PCG-36 | Huawei | Rel-14 | RP-70 |  |  |  |  |
| 3554 | 1399.4 | **LTE Advanced inter-band Carrier Aggregation Rel-14 for 3DL/3UL** | 328d? | 2015-12-15 A | 2017-03-15 A | 100% |  |  |  |  |  |  | R4 | 7872h | 7872h | LTE_CA_R14_3DL3UL | PCG-36 | Nokia Networks | Rel-14 | RP-70 |  |  |  |  |
| 3555 | 1399.4.1 | Core part: LTE Advanced inter-band Carrier Aggregation Rel-14 for 3DL/3UL | 328d? | 2015-12-15 A | 2017-03-15 A | 100% |  |  |  |  |  | finish no earlier than 2017-03-15 | R4 | 2624h | 2624h | LTE_CA_R14_3DL3UL-Core | PCG-36 | Nokia Networks | Rel-14 | RP-70 |  |  |  | 36.714-03-03 |
| 3556 | 1399.4.2 | Perf. part: LTE Advanced inter-band Carrier Aggregation Rel-14 for 3DL/3UL | 328d? | 2015-12-15 A | 2017-03-15 A | 100% |  |  |  |  |  | finish no earlier than 2017-03-15 | R4 | 2624h | 2624h | LTE_CA_R14_3DL3UL-Perf | PCG-36 | Nokia Networks | Rel-14 | RP-70 |  |  |  |  |
| 3557 | 1399.5 | **LTE Advanced inter-band Carrier Aggregation Rel-14 for xDL/2UL with x=3,4,5** | 394d? | 2015-12-15 A | 2017-06-15 | 48% | 206.85d? |  |  |  | 2277d |  | R4 | 9456h | 4240.77h | LTE_CA_R14_xDL2UL | PCG-36 | LG Electronics | Rel-14 | RP-70 |  |  |  |  |
| 3558 | 1399.5.1 | Core part: LTE Advanced inter-band Carrier Aggregation Rel-14 for xDL/2UL with x=3,4,5 | 394d? | 2015-12-15 A | 2017-06-15 | 95% | 19.7d? |  |  |  | 2277d | finish no earlier than 2017-06-15 | R4 | 3152h | 2994.4h | LTE_CA_R14_xDL2UL-Core | PCG-36 | LG Electronics | Rel-14 | RP-70 |  |  |  | 36.714-00-02 |
| 3559 | 1399.5.2 | Perf. part: LTE Advanced inter-band Carrier Aggregation Rel-14 for xDL/2UL with x=3,4,5 | 394d? | 2015-12-15 | 2017-06-15 |  |  |  |  |  | 2277d | finish no earlier than 2017-06-15 | R4 | 3152h |  | LTE_CA_R14_xDL2UL-Perf | PCG-36 | LG Electronics | Rel-14 | RP-70 |  |  |  |  |
| 3560 | 1399.6 | **LTE Advanced inter-band Carrier Aggregation Rel-14 for 4DL/1UL** | 394d? | 2015-12-15 A | 2017-06-15 | 95% | 19.69d? |  |  |  | 2277d |  | R4 | 9456h | 8481.62h | LTE_CA_R14_4DL1UL | PCG-36 | Ericsson | Rel-14 | RP-70 |  |  |  |  |
| 3561 | 1399.6.1 | Core part: LTE Advanced inter-band Carrier Aggregation Rel-14 for 4DL/1UL | 394d? | 2015-12-15 A | 2017-06-15 | 95% | 19.7d? |  |  |  | 2277d | finish no earlier than 2017-06-15 | R4 | 3152h | 2994.4h | LTE_CA_R14_4DL1UL-Core | PCG-36 | Ericsson | Rel-14 | RP-70 |  |  |  | 36.714-04-01 |
| 3562 | 1399.6.2 | Perf. part: LTE Advanced inter-band Carrier Aggregation Rel-14 for 4DL/1UL | 394d? | 2015-12-15 A | 2017-06-15 | 95% | 19.7d? |  |  |  | 2277d | finish no earlier than 2017-06-15 | R4 | 3152h | 2994.4h | LTE_CA_R14_4DL1UL-Perf | PCG-36 | Ericsson | Rel-14 | RP-70 |  |  |  |  |
| 3563 | 1399.7 | **LTE Advanced intra-band Carrier Aggregation for xDL/yUL including contiguous and non-contiguous spectrum** | 394d? | 2015-12-15 A | 2017-06-15 | 82% | 70.92d? |  |  |  | 2277d |  | R4 | 9456h | 7084.9h | LTE_CA_R14_intra | PCG-36 | Ericsson | Rel-14 | RP-70 |  |  |  |  |
| 3564 | 1399.7.1 | Core part: LTE Advanced intra-band Carrier Aggregation for xDL/yUL including contiguous and non-contiguous spectrum | 394d? | 2015-12-15 A | 2017-06-15 | 82% | 70.92d? |  |  |  | 2277d | finish no earlier than 2017-06-15 | R4 | 3152h | 2584.64h | LTE_CA_R14_intra-Core | PCG-36 | Ericsson | Rel-14 | RP-70 |  |  |  | 36.714-00-00 |
| 3565 | 1399.7.2 | Perf. part: LTE Advanced intra-band Carrier Aggregation for xDL/yUL including contiguous and non-contiguous spectrum | 394d? | 2015-12-15 A | 2017-06-15 | 82% | 70.92d? |  |  |  | 2277d | finish no earlier than 2017-06-15 | R4 | 3152h | 2584.64h | LTE_CA_R14_intra-Perf | PCG-36 | Ericsson | Rel-14 | RP-70 |  |  |  |  |

Notes:
- 3544: Acronym changed from "LTE_CA_Rel-13" to "LTE_CA_Rel13"
- 3546: 28/1/16: 36.714-05-01 added¦22/3/16: Compl:0%->15%¦22/3/16: WID: RP-151671->RP-1606151/7/16: Compl:15%->40%¦26/9/16: Compl:40%->60%¦20/12/16: Compl ¦21/3/17
- 3547: 22/3/16: WID: RP-151671->RP-1606151/7/16: WID: RP-160615->RP-16105226/9/16: WID: RP-161052->RP-161496¦20/12/16: Compl:0%->90% ¦21/3/17: Compl:90%->95%;
- 3549: 28/1/16: 36.714-02-01 added¦22/3/16: Compl:0%->20%¦22/3/16: WID: RP-152196->RP-160616¦1/7/16: Compl:20%->30%¦1/7/16: WI26/9/16: Compl:30%->50%¦20/12/16: Com 21/3/17:
- 3550: 22/3/16: WID: RP-152196->RP-1606161/7/16: Compl:0%->30%1/7/16: WID: RP-160616->RP-161202¦26/9/16: Compl:30%->50% 20/12/16: Compl:50%->75% 21/3/17: Compl:75%->80%;
- 3552: 28/1/16: 36.714-02-02 added;22/3/16: Compl:0%->20%22/3/16: WID: RP-152237->RP-160192¦1/7/16: Compl:20%->40%¦26/9/16: Compl:40%->60%¦20/12/16: C ¦21/3/17:
- 3553: ¦22/3/16: WID: RP-152237->RP-1601921/7/16: WID: RP-160192->RP-16094726/9/16: WID: RP-160947->RP-161676¦20/12/16: Compl:0%->80%¦21/3/17: Compl:80%->90
- 3555: 28/1/16: 36.714-03-03 added;22/3/16: Compl:0%->1%1/7/16: Compl:1%->15%¦21/3/17: Compl:15%->100%
- 3556: ¦1/7/16: Compl:0%->15%21/3/17: Compl:15%->100%
- 3558: 28/1/16: 36.714-00-02 added¦22/3/16: Compl:0%->10%¦22/3/16: WID: RP-152246->RP-160148¦1/7/16: Compl:10%->40%¦26/9/16: Compl:40%->70%¦20/¦21/3/17:
- 3559: 22/3/16: WID: RP-152246->RP-1601481/7/16: WID: RP-160148->RP-160748¦26/9/16: WID: RP-160748->RP-161487¦20/12/16: WID: RP-161487->RP-16203621/3/17:
- 3561: 28/1/16: 36.714-04-01 added;22/3/16: Compl:0%->30%22/3/16: WID: RP-152249->RP-1606141/7/16: Compl:30%->38%¦26/9/16: Compl:38%->74%¦20/12/16: Compl:74%->9521/3/1
- 3562: ¦22/3/16: WID: RP-152249->RP-160614¦1/7/16: Compl:0%->38%¦1/7/16: WID: RP-160614->RP-16082126/9/16: Compl:38%->0%¦20/12/16: Compl:0%->95% ¦21/3/17: CD:Wed 1
- 3564: 28/1/16: 36.714-00-00 added;22/3/16: Compl:0%->60%22/3/16: WID: RP-152250->RP-160613¦1/7/16: Compl:60%->50%¦1/7/16: WID: RP-160613¦26/9/16: Compl:50%->44%¦20/12/16:21/3/1
- 3565: ¦22/3/16: WID: RP-152250->RP-1606131/7/16: Compl:0%->50%1/7/16: WID: RP-160613->RP-16082226/9/16: WID: RP-160822->RP-161473¦20/12/16: Compl:50%->64% 21/3/17: Compl:64%->

| ID | WBS | Task | Type | Duration | Start | Finish | Complete | Remaining | Baseline start | Baseline finish | Baseline duration | Total slack | Constraint | Resources | Work | Actual work | Acronym | PCG approved | WI rapporteur name | Release | TSG approved | Impacted TSs and TRs | Status Report | WI rapporteur e-mail | MCC resp | Acronym_3GU_Export | Special Focus Doc | TSG stopped |
| --- | --- | --- | --- | --- | --- | --- | --- | --- | --- | --- | --- | --- | --- | --- | --- | --- | --- | --- | --- | --- | --- | --- | --- | --- | --- | --- | --- | --- |
| 3566 | 1399.8 | **LTE Advanced inter-band Carrier Aggregation Rel-14 for 3DL/1UL** |  | 394d? | 2015-12-15 A | 2017-06-15 | 90% | 39.4d? |  |  |  | 2277d |  | R4 | 9456h | 7904.07h | LTE_CA_R14_3DL1UL | PCG-36 | Huawei | Rel-14 | RP-70 |  |  |  |  |  |  |  |
| 3567 | 1399.8.1 | Core part: LTE Advanced inter-band Carrier Aggregation Rel-14 for 3DL/1UL |  | 394d? | 2015-12-15 A | 2017-06-15 | 90% | 39.4d? |  |  |  | 2277d | finish no earlier than 2017-06-15 | R4 | 3152h | 2836.8h | LTE_CA_R14_3DL1UL-Core | PCG-36 | Huawei | Rel-14 | RP-70 | 36.714-03-01 |  |  |  |  |  |  |
| 3568 | 1399.8.2 | Perf. part: LTE Advanced inter-band Carrier Aggregation Rel-14 for 3DL/1UL |  | 394d? | 2015-12-15 A | 2017-06-15 | 90% | 39.4d? |  |  |  | 2277d | finish no earlier than 2017-06-15 | R4 | 3152h | 2836.8h | LTE_CA_R14_3DL1UL-Perf | PCG-36 | Huawei | Rel-14 | RP-70 |  |  |  |  |  |  |  |
| 3569 | 1399.9 | UE Conformance Test Aspects – Rel-14 CA configurations |  | 1376d? | 2016-06-15 A | 2021-09-21 A | 100% |  |  |  |  |  | finish no earlier than 2021-09-21 | R5 | 11008h | 11008h | LTE_CA_R14-UEConTest | 37 | Ericsson | Rel-14 | 72 |  | RP-211865 |  |  |  |  |  |
| 3570 | 1400 | Release 14 Studies |  | 323d? | 2014-09-17 A | 2015-12-11 A | 100% |  |  |  |  |  | finish no earlier than 2015-12-11 | SP; RP; CP; GP | 10336h | 10336h |  |  |  | Rel-14 |  |  |  |  |  |  |  |  |
| 3571 | 1401 | Study on channel model for frequency spectrum above 6 GHz |  | 197d? | 2015-09-15 A | 2016-06-15 A | 100% |  |  |  |  |  | finish no earlier than 2016-06-15 | R1 | 1576h | 1576h | FS_6GHz_CH_model | 35 | Samsung | Rel-14 | 69 | 38.900 |  |  |  |  |  |  |
| 3572 | 1402 | Study on Scenarios and Requirements for Next Generation Access Technologies |  | 264d? | 2015-12-15 A | 2016-12-15 A | 100% |  |  |  |  |  | finish no earlier than 2016-12-15 | RP | 2112h | 2112h | FS_NG_SReq | 36 | CMCC | Rel-14 | 70 | 38.xxx |  |  |  |  |  |  |
| 3573 | 1403 | Study on NB-IoT RF requirement for coexistence with CDMA |  | 133d? | 2016-06-15 A | 2016-12-15 A | 100% |  |  |  |  |  | finish no earlier than 2016-12-15 | R4 | 1064h | 1064h | FS_NB_IOT_CDMA_coex | 37 | China Telecom | Rel-14 | 72 | 36.752 |  |  |  |  |  |  |
| 3574 | 1404 | Study on need for Multiple Access Point Names |  | 464d? | 2013-09-12 A | 2015-06-19 A | 100% |  | 2013-09-12 | 2014-12-10 | 327d? |  | finish no earlier than 2015-06-19 | S1 | 3704h | 3704h | FS_MAPN | 31 | Giesecke & Devrient | Rel-14 | 61 | 22.802 |  | Ilario.macchi@gi-de.com | Alain | FS_MAPN |  |  |
| 3575 | 1405 | Study on Multimedia Broadcast Supplement for Public Warning System |  | 264d? | 2013-12-11 A | 2014-12-12 A | 100% |  | 2013-12-11 | 2014-09-17 | 202d? |  | finish no earlier than 2014-12-12 | S1 | 2104h | 2104h | FS_MBSP | 32 | Qualcomm | Rel-14 | 62 | 22.815 |  | Eddy Hall (edhall@qti.qualcomm.com) | Alain | FS_MBSP | Public Safety (I-A) |  |
| 3576 | 1406 | Study on service aspects for dealing with User Control over spoofed calls |  | 271d? | 2014-03-07 A | 2015-03-20 A | 100% |  | 2014-03-07 | 2014-12-10 | 199d? |  | finish no earlier than 2015-03-20 | S1 | 2168h | 2168h | FS_UC_SPOOF | 32 | Sprint | Rel-14 | 63 | 22.898 |  | Gregory.schumacher@sprint.com | Alain | FS_UC_SPOOF |  |  |
| 3577 | 1407 | Study on User Location Reporting Support enhancements |  | 261d? | 2014-06-19 A | 2015-06-17 A | 100% |  | 2014-06-18 | 2015-06-17 | 261d? |  | finish no earlier than 2015-06-17 | S1 | 2088h | 2088h | FS_eULRS | 33 | China Unicom | Rel-14 | 64 | 22.899 |  | Zhuoyun Zhang ( zhangzy910@chinaunicom.cn) |  | FS_eULRS |  |  |
| 3578 | 1408 | Study on Control of Applications when Third party Servers encounter difficulties |  | 259d? | 2014-06-19 A | 2015-06-15 A | 100% |  | 2014-06-18 | 2014-12-10 | 126d? |  | finish no earlier than 2015-06-15 | S1 | 2072h | 2072h | FS_CATS | 33 | KDDI | Rel-14 | 64 | 22.818 |  | Eriko Yoshida (er-yoshida@kddi.com) |  | FS_CATS |  |  |
| 3579 | 1409 | Study on Paging Policy Enhancements and Procedure Optimizations in LTE |  | 176d? | 2015-04-14 A | 2015-12-15 A | 100% |  |  |  |  |  | finish no earlier than 2015-12-15 | S1 | 1408h | 1408h | FS_PPEPO_LTE | 34 | Zhuoyun Zhang (China Unicom) | Rel-14 | 67 | New 22.838 |  | zhangzy910@chinaunicom.cn |  |  |  |  |
| 3580 | 1410 | Study on Latency reduction techniques for LTE |  | 328d? | 2015-03-16 A | 2016-06-15 A | 100% |  |  |  |  |  | finish no earlier than 2016-06-15 | R2 | 2624h | 2624h | FS_LTE_LATRED | 34 | Ericsson | Rel-14 | 67 | 36.881 |  |  |  |  |  |  |
| 3581 | 1411 | Study on High Power LTE UE for Band 41 |  | 263d? | 2015-06-15 A | 2016-06-15 A | 100% |  |  |  |  |  | finish no earlier than 2016-12-15 | R4 | 2104h | 2104h | FS_LTE_B41_HPUE | 35 | Sprint | Rel-14 | 68 | 36.886 |  |  |  |  |  |  |
| 3582 | 1412 | Study on Media and Quality Aspects of SRVCC Enhancements |  | 192d? | 2015-06-18 A | 2016-03-11 A | 100% |  |  |  |  |  | finish no earlier than 2016-03-11 | S4 | 1536h | 1536h | FS_SETA_S4 | 35 | Frédéric Gabin, Ericsson LM | Rel-14 | 68 | New 26.916; 26.114 |  | frederic . gabin @ ericsson . com |  |  |  |  |
| 3583 | 1413 | Stopped - Study on SON for eCoMP for LTE |  | 3d? | 2016-06-14 A | 2016-06-16 A | 100% |  |  |  |  |  | start no earlier than 2016-06-14 | R3 | 24h | 24h | delFS_LTE_SON_eCOMP | 37 | Nokia | Rel-14 | 72 | 23.228; 23.237 |  |  |  |  |  | 80 |
| 3584 | 1414 | Study on UICC power optimization for MTC |  | 133d? | 2016-06-15 A | 2016-12-15 A | 100% |  |  |  |  |  |  | C6 | 1064h | 1064h | FS_UICC_MTC_OPT | 36 | Berionne, Michele | Rel-14 | 70 | 31.970 |  | micheleb [at] qti [dot] qualcomm [dot] com |  |  |  |  |
| 3585 | 1415 | Study on Server and Network Assisted DASH for 3GPP |  | 209d? | 2016-03-01 A | 2016-12-15 A | 100% |  |  |  |  |  | finish no earlier than 2016-12-15 | S4 | 1672h | 1672h | FS_SAND | 36 | Ozgur Oyman, Intel | Rel-14 | 71 | TR26.957 |  | ozgur.oyman@intel.com |  |  |  |  |
| 3586 | 1416 | Study on MBMS usage for mission critical communication services | milestone | 0d? | 2016-03-01 A | 2016-03-01 | 99% | 0d? |  |  |  | 2616d | finish no earlier than 2016-12-15 | C1 |  |  | FS_MBMS_MCservices | 36 | Magnus Tränk, Ericsson LM | Rel-14 | 71 | 23.780 |  | magnus.trank@ericsson.com |  |  |  |  |
| 3587 | 1417 | Study on enhancement of VoLTE |  | 134d? | 2016-03-15 A | 2016-09-15 A | 100% |  |  |  |  |  | finish no earlier than 2016-09-15 | R2 | 1072h | 1072h | FS_LTE_eVoLTE | 36 | CMCC | Rel-14 | 71 | 36.750 |  |  |  |  |  |  |
| 3588 | 1418 | Study on HSPA and LTE Joint Operation |  | 199d? | 2016-03-15 A | 2016-12-15 A | 100% |  |  |  |  |  | finish no earlier than 2016-12-15 | R3 | 1592h | 1592h | FS_UTRA_LTE_JOP | 36 | China Unicom | Rel-14 | 71 | New 37.805 |  |  |  |  |  |  |
| 3589 | 1419 | Study on LTE Advanced Carrier Aggregation of Band 3 and Band 39 |  | 263d? | 2016-03-15 A | 2017-03-15 A | 100% |  |  |  |  |  | finish no earlier than 2017-03-15 | R4 | 2104h | 2104h | FS_LTE_CA_B3_B39 | 36 | ZTE | Rel-14 | 71 |  |  |  |  |  |  |  |
| 3590 | 1420 | Study on Context Aware Service Delivery in RAN for LTE |  | 263d? | 2016-03-15 A | 2017-03-15 A | 100% |  |  |  |  |  | finish no earlier than 2017-03-15 | R3 | 2104h | 2104h | FS_LTE_context | 36 | CMCC | Rel-14 | 71 |  |  |  |  |  |  |  |
| 3591 | 1421 | Study on further enhancements to Coordinated Multi-Point (CoMP) Operation for LTE |  | 263d? | 2016-03-15 A | 2017-03-15 A | 100% |  |  |  |  |  | finish no earlier than 2017-03-15 | R1 | 2104h | 2104h | FS_feCOMP_LTE | 36 | Intel | Rel-14 | 71 |  |  |  |  |  |  |  |
| 3592 | 1422 | Study on Determination of Completeness of Charging Information in IMS |  | 267d? | 2015-03-05 A | 2016-03-11 A | 100% |  |  |  |  |  | finish no earlier than 2016-03-11 | S5 | 2136h | 2136h | FS_DCCHII | 34 | Jesske, Roland | Rel-14 | 67 | 32.xyz |  | r.jesske@telekom.de |  |  |  |  |
| 3593 | 1423 | Study on Interactivity Support for 3GPP-based Streaming and Download Services |  | 587d? | 2014-12-12 A | 2017-03-10 A | 100% |  |  |  |  |  | finish no earlier than 2017-03-10 | S4 | 4696h | 4696h | FS_IS3 | 34 | Lo, Charles, Qualcomm | Rel-14 | 66 | 26.953 |  | clo@qti.qualcomm.com |  |  |  |  |
| 3594 | 1424 | Study on MBMS usage and codecs for MCPTT call and MC Video Service |  | 199d? | 2016-06-13 A | 2017-03-15 A | 100% |  |  |  |  |  | finish no earlier than 2017-03-15 | S4 | 1592h | 1592h | FS_MCP_V | 37 | Zhiming Li, Huawei | Rel-14 | 72 | 26.880 |  | lizhiming@huawei.com |  |  |  |  |
| 3595 | 1425 | Study on MBMS Extensions for Provisioning and Content Ingestion |  | 196d? | 2016-06-13 A | 2017-03-10 A | 100% |  |  |  |  |  | finish no earlier than 2017-03-10 | S4 | 1568h | 1568h | FS_xMBMS | 37 | Kyungmo Park, sk telecom | Rel-14 | 72 | 26.981 |  | kyungmo.park@sk.com |  |  |  |  |
| 3596 | 1426 | Study on global application of LTE Band 11 and of LTE Band 21 UEs |  | 133d? | 2016-06-15 A | 2016-12-15 A | 100% |  |  |  |  |  | finish no earlier than 2016-12-15 | R4 | 1064h | 1064h | FS_LTE_B11_B21_global | 37 | SoftBank | Rel-14 | 72 | 36.745 |  |  |  |  |  |  |
| 3597 | 1427 | Study on Downlink MIMO for GERAN |  | 68d? | 2016-06-15 A | 2016-09-15 A | 100% |  |  |  |  |  | finish no earlier than 2016-09-15 | R6 | 544h | 544h | FS_DOMIMO_RAN6 | 37 | Nokia, Alcatel-Lucent Shanghai Bell | Rel-14 | 72 |  |  |  |  |  |  |  |
| 3598 | 1428 | Release 14 studies on 5G MObile Network for Advanced communications |  | 490d? | 2015-02-02 A | 2016-12-15 A | 100% |  |  |  |  |  |  | S1 | 2160h | 2160h |  | 34 | Adrian Neal (Vodafone) | Rel-14 | 67 | New 22.891 |  | adrian.neal@vodafone.com |  |  |  |  |

Notes:
- 3567: 28/1/16: 36.714-03-01 added;22/3/16: Compl:0%->15%22/3/16: WID: RP-152278->RP-1605821/7/16: Compl:15%->40%1/7/1626/9/16: Compl:40%->60%¦20/12/16: Compl:60%->80 21/3/1
- 3568: 22/3/16: WID: RP-152278->RP-160582¦1/7/16: WID: RP-160582->RP-160945¦26/9/16: WID: RP-160945->RP-161674¦20/12/16: Compl:0%->80%21/3/17: Compl:80%->90%;
- 3569: testing REL-14 CA basket WIs: LTE_CA_R14_intra-Core, LTE_CA_R14_2DL1UL-Core, LTE_CA_R14_3DL1UL-Core, LTE_CA_R14_4DL1UL-Core, LTE_CA_R14_5DL1UL-Core, LTE_CA_R14_2DL2UL-Core, LTE_CA_R14_xDL2UL-Core, LTE_CA_R14_3DL3UL-Core ;; 8/10/20: 20%->38; 8/10/20: F
- 3570: -
- 3571: will start only in RAN in Q4/15¦28/1/16: 38.900 added¦22/3/16: Compl:10%->20%¦22/3/16: WID: RP-151606->RP-160210¦1/7/16: Compl:20%->100%. 2/12/16: Moved to Rel-15 according JMM email to move all 38.xxx related WIDs to Rel-15¦21/3/17: Stat Rep: -->
- 3572: 22/3/16: Compl:0%->80%1/7/16: WID: RP-152257->RP-160811. 18/9/16: FCD: Sept 16, 80->95%26/9/16: Compl:95%->100%¦14/12/16: FCD:09/16->12/16¦14/12/16: 100%->9820/12/16: Compl:98%->100%20/12/16: CD:Mon 12/12/16->Thu 15/12/1620/12/16: Release: Rel-15->Re
- 3573: ¦26/9/16: Compl:0%->35%¦6/10/16: 36.752 added¦20/12/16: Compl:35%->100%
- 3574: SP#65 moved to Rel-14. Completion 12/14=>03/15. Triggered by S1-133134 LS on GSMA Connected Living Programme Request for APN Storage in the SIM. Dec.14: 50->70%, CD: 03/15->06/15. Mar.15: 90%¦June2015: Compl:90%->100
- 3575: SP#65 completion 09/14=>12/14. Moved to Rel-14. TR 22.815v100 for Information. Linked to Rel-9 Feature PWS. Dec.14:70->100%
- 3576: SP#65 moved to Rel-14. Linked to SA3 Rel-11 TR 33.838 PUCI and Rel-12 ongoing study TR 33.831 (FS_SPOOF). Dec.14: 70->90, CD: 12/14->03/15. Mar.15: 100%
- 3577: SP#65 moved to Rel-14. Linked to Rel-12 SA2 TR 23.843 Study on Core Network Overload solutions (FS_CNO) and Rel-13 Feature Service Exposure and Enablement Support (SEES). Dec.14: 30->70%. Mar.15: 90%¦June2015: Compl:90%->100
- 3578: SP#65 completion 12/14=>03/15. Moved to Rel-14. Linked to Rel-13 Feature SEES and Rel-13 TR 22.806 (FS_ACDC). Dec.14: 30->60%, WID SP-140246->SP-140758, CD: 12/14->03/15. Mar.15: CD: 03/13->06/15. 60->90%¦June2015: Compl:90%->100
- 3579: 1/4/15:TR number added¦June2015: Compl:0%->40¦07/09/15: 40%->60¦7/12/15: 60%->100
- 3580: 03/07/15: Compl:0%->10% 03/07/15: Stat Rep: -->RP-150780 03/07/15: Release: Rel-13->Rel-14 29/09/15: Compl:10%->25% 29/09/15: Stat Rep: RP-150780->RP-151286 22/3/16: Compl:50%->60%;
- 3581: 7/9/15: TR added 29/09/15: Compl:0%->1% 29/09/15: Stat Rep: -->RP-151436 ¦22/3/16: Compl:10%->40%¦22/3/16: WID: RP-151104->RP-1600921/7/16: Compl
- 3582: Aug2015: 0%->25¦07/09/15: 25%->30¦7/12/15: 30%->80, FCD: 12/15->03/16, MOVED TO REL-14¦7/3/16: 80%->100
- 3583: 26/9/16: Compl:0%->10%. 1/12/16: Deleted: 720085 was allocated twice: to FS_LTE_SON-ECOMP (now in 720063) and to ROBVOLTE (now in 720301)
- 3584: 7/3/16: 0%->100¦5/6/17: 71%->100
- 3585: 11/6/16: 0%->10¦19/9/16: 10%->60¦1/12/16: 60%->100
- 3586: 11/6/16: 0%->35. Name corrected¦19/9/16: WID:SP-160201->SP-160525¦FCD: 09/16->12/16¦19/9/16: 35%->60¦23/9/16: WID:SP-160525->SP-160728¦1/12/16: 60%->95¦3/3/17: 95%->100
- 3587: 1/7/16: Compl:0%->75%1/7/16: WI¦28/7/16: 36.750 added¦26/9/16: Compl:75%->100%
- 3588: ¦1/7/16: Compl:0%->30%¦26/9/16: Compl:30%->80%¦ 20/12/16: Compl:80%->100%¦
- 3589: intention to capture results in existing TR 36.714-02-01 ¦1/7/16: Compl:0%->30%¦26/9/16: Compl:30%->50%¦20/12/16: Compl ¦21/3/17: Compl:8
- 3590: 1/7/16: Compl:0%->25%1/26/9/16: Compl:25%->40%¦20/12/16: Compl:40%->70% ¦21/3/17: Compl:70%->100%
- 3591: ¦1/7/16: Compl:0%->15%¦26/9/16: Compl:15%->30%¦20/12/16: Compl:30%->80%21/3/17: Compl:80%->100%
- 3592: 11/03/15: WID changed from FS_DCCII to FS_DCCHII as per SA5 chair request¦June2015: Compl:0%->7¦07/09/15: 7%->15¦7/12/15: 15%->60, FCD: 09/15->03/16¦7/3/16: 60%->100. 22/3/16: Rel-13->Rel-14
- 3593: TR number added. Mar. 15: 0->5%¦June2015: Compl:5%->10¦Aug2015: 10%->15¦07/09/15: 15%->30, FCD: 12/15->03/16¦7/3/16: 30%->40. 15/4/16: moved from Rel-13. FCD: 11/3/16->23/9/16¦11/6/16: 40%->50¦19/9/16: 50%->70, FCD:09/16->12/16¦1/12/16: 70%->80;
- 3594: 28/7/16: 26.880 added¦19/9/16: 0%->30, FCD: 12/16->03/17¦1/12/16: 30%->60¦6/3/17: 60%->100
- 3595: 28/7/16: 26.981 added¦19/9/16: 0%->30¦1/12/16: 30%->50¦1/12/16: FCD:12/16->03/17¦6/3/17: 50%->100
- 3596: 26/9/16: Compl:0%->30%¦6/10/16: 36.745 added¦20/12/16: Compl:30%->100%
- 3597: continuation of GERAN SI UID 590034, DOMIMO under RAN626/9/16: Compl:0%->100%
- 3598: 11/3: WID: SP-150050->150142¦June2015: Compl:0%->20¦07/09/15: 20%->60. 07/12/15: Created by MCC as BB to dissociate SA1 versus SA2 aspects

| ID | WBS | Task | Type | Duration | Start | Finish | Complete | Baseline start | Baseline finish | Baseline duration | Constraint | Resources | Work | Actual work | Acronym | PCG approved | Impacted TSs and TRs | WI rapporteur name | WI rapporteur e-mail | Release | TSG approved | MCC resp | Special Focus Doc | Acronym_3GU_Export | Status Report | TSG stopped |
| --- | --- | --- | --- | --- | --- | --- | --- | --- | --- | --- | --- | --- | --- | --- | --- | --- | --- | --- | --- | --- | --- | --- | --- | --- | --- | --- |
| 3599 | 1429 | **Study on Stage 1 for New Services and Markets Technology Enablers** |  | 355d? | 2015-02-02 A | 2016-06-10 A | 100% |  |  |  |  | S1 | 10120h | 10120h | FS_SMARTER | 34 | New 22.891 | Adrian Neal (Vodafone) | adrian.neal@vodafone.com | Rel-14 | 67 |  |  |  |  |  |
| 3600 | 1429.1 | General aspects of FS_SMARTER SA1 |  | 270d? | 2015-02-02 A | 2016-02-12 A | 100% |  |  |  | finish no earlier than 2016-02-12 | S1 | 2160h | 2160h | FS_SMARTER | 34 | New 22.891 | Adrian Neal (Vodafone) | adrian.neal@vodafone.com | Rel-14 | 67 |  |  |  |  |  |
| 3601 | 1429.2 | FS_SMARTER – massive Internet of Things |  | 160d? | 2015-11-02 A | 2016-06-10 A | 100% |  |  |  | finish no earlier than 2016-06-10 | S1 | 1280h | 1280h | FS_SMARTER-mIoT | 36 | New 22.861 | Adrian Neal (Vodafone) | adrian.neal@vodafone.com | Rel-14 | 70 |  |  |  |  |  |
| 3602 | 1429.3 | FS_SMARTER – Critical Communications |  | 160d? | 2015-11-02 A | 2016-06-10 A | 100% |  |  |  | finish no earlier than 2016-06-10 | S1 | 1280h | 1280h | FS_SMARTER-CRIC | 36 | New 22.862 | Kanerva, Mikko | mikko.kanerva@nokia.com | Rel-14 | 70 |  |  |  |  |  |
| 3603 | 1429.4 | FS_SMARTER – enhanced Mobile Broadband |  | 160d? | 2015-11-02 A | 2016-06-10 A | 100% |  |  |  | finish no earlier than 2016-06-10 | S1 | 1280h | 1280h | FS_SMARTER-eMBB | 36 | New 22.863 | Laurence Meriau | laurence.meriau@huawei.com | Rel-14 | 70 |  |  |  |  |  |
| 3604 | 1429.5 | FS_SMARTER – Network Operation |  | 160d? | 2015-11-02 A | 2016-06-10 A | 100% |  |  |  | finish no earlier than 2016-06-10 | S1 | 1280h | 1280h | FS_SMARTER-NEO | 36 | New 22.864 | Lu Lu | lulu@chinamobile.com | Rel-14 | 70 |  |  |  |  |  |
| 3605 | 1430 | SA2 aspects on Study on Architecture and Security for next Generation System |  | 270d? | 2015-12-07 A | 2016-12-15 A | 100% |  |  |  | finish no earlier than 2016-12-15 | S2 | 2160h | 2160h | FS_NextGen | 36 | 23.799 | suntao@chinamobile.com, devaki.chandramouli@nokia.com | suntao@chinamobile.com, devaki.chandramouli@nokia.com | Rel-14 | 70 |  |  |  |  |  |
| 3606 | 1431 | Study on New Radio (NR) Access Technology |  | 263d? | 2016-03-15 A | 2017-03-15 A | 100% |  |  |  | finish no earlier than 2017-03-15 | R1 | 2104h | 2104h | FS_NR_newRAT | 36 | 38.801; 38.912; 38.802; 38.901; 38.805 | NTT DOCOMO |  | Rel-14 | 71 |  |  |  |  |  |
| 3607 | 1432 | --- RELEASE 13 --- |  | 253.25d? | 2013-12-11 A | 2014-11-25 A | 100% | 2015-04-14 | 2015-12-25 | 183.25d? |  | SP; RP; CP; GP | 8104h | 8104h |  |  |  |  |  | Rel-13 |  |  |  |  |  |  |
| 3608 | 1433 | **Mission Critical Push To Talk over LTE (MCPTT)** |  | 1183d? | 2013-12-11 A | 2018-06-15 A | 100% | 2013-12-11 | 2015-06-17 | 397d? |  |  | 39400h | 39400h | MCPTT | 32 | Stage 1/2; | NIST | david.cypher@nist.gov | Rel-13 | 62 | Alain | Public Safety (A-A) | MCPTT |  |  |
| 3609 | 1433.1 | Study on Application Architecture to support MCPTT |  | 326d? | 2014-06-23 A | 2015-09-16 A | 100% | 2014-06-18 | 2014-12-10 | 126d? | finish no earlier than 2015-09-16 | S6 | 2608h | 2608h | MCPTT | 33 | New 23.779 | Yannick Lair | yannick.lair@lge.com | Rel-13 | 64 |  | Public Safety (A-A) |  |  |  |
| 3610 | 1433.2 | SA2 Study on Architecture Enhancements at the EPS and IMS Level to Support MCPTT |  | 69d? | 2015-03-13 A | 2015-06-17 A | 100% |  |  |  | finish no earlier than 2015-06-17 | S2 | 552h | 552h | MCPTT | 34 |  | Randy Bloomfield (randy@its.bldrdoc.gov) | Randy Bloomfield (randy@its.bldrdoc.gov) | Rel-13 | 67 |  |  |  |  |  |
| 3611 | 1433.3 | Study on Security Enhancements for MCPTT |  | 261d? | 2015-03-13 A | 2016-03-11 A | 100% |  |  |  | finish no earlier than 2016-03-11 | S3 | 2088h | 2088h | MCPTT | 34 | 33.879; 33.280; 39.880 | Peter Haigh (peter.haigh at cesg.gsi.gov.uk) | Peter Haigh (peter.haigh at cesg.gsi.gov.uk) | Rel-13 | 67 |  |  |  |  |  |
| 3612 | 1433.4 | Study on media, codecs and MBMS enhancements for MCPTT |  | 326d? | 2014-12-12 A | 2016-03-11 A | 100% |  |  |  | finish no earlier than 2016-03-11 | S4 | 2608h | 2608h | MCPTT | 34 | New 26.879 | Zhiming Li (lizhiming@huawei.com) | Zhiming Li (lizhiming@huawei.com) | Rel-13 | 67 |  |  |  |  |  |
| 3613 | 1433.5 | Stage 1 for MCPTT |  | 263d? | 2013-12-11 A | 2014-12-12 A | 100% | 2013-12-11 | 2014-12-10 | 261d? | finish no earlier than 2014-12-12 | S1 | 2104h | 2104h | MCPTT | 32 | New 22.179 | NIST | david.cypher@nist.gov | Rel-13 | 62 | Alain | Public Safety (A-A) |  | SP-140502 |  |
| 3614 | 1433.6 | Functional architecture and information flows to support MCPTT |  | 127d? | 2015-06-18 A | 2015-12-11 A | 100% | 2014-06-18 | 2014-12-10 | 126d? | finish no earlier than 2015-12-11 | S6 | 1016h | 1016h | MCPTT | 33 | New 23.179 | Yannick Lair | yannick.lair@lge.com | Rel-13 | 64 |  | Public Safety (A-A) |  |  |  |
| 3615 | 1433.7 | Security of MCPTT |  | 326d? | 2014-12-12 A | 2016-03-11 A | 100% |  |  |  | finish no earlier than 2016-03-11 | S3 | 2608h | 2608h | MCPTT | 34 | 33.179 | Peter Haigh (peter.haigh at cesg.gsi.gov.uk) | Peter Haigh (peter.haigh at cesg.gsi.gov.uk) | Rel-13 | 66 |  |  |  |  |  |
| 3616 | 1433.8 | MCPTT Codecs and media handling |  | 267d? | 2015-03-05 A | 2016-03-11 A | 100% |  |  |  | finish no earlier than 2016-03-11 | S4 | 2136h | 2136h | MCPTT | 34 | 26.346; new 26.179 | Zhiming Li (lizhiming@huawei.com) | Zhiming Li (lizhiming@huawei.com) | Rel-13 | 67 |  |  |  |  |  |
| 3617 | 1433.9 | **MCPTT protocol aspects** |  | 215d? | 2015-09-07 A | 2016-06-30 A | 100% |  |  |  |  | ct | 17408h | 17408h | MCPTT-CT | 35 |  | Keith Drage, Alcatel-Lucent |  | Rel-13 | 69 |  |  |  |  |  |
| 3618 | 1433.9.1 | **CT1 aspects for MCPTT protocol aspects** |  | 135d? | 2015-09-07 A | 2016-03-11 A | 100% |  |  |  |  | C1 | 10800h | 10800h | MCPTT-CT | 35 | 24.379; 24.380 24.38; 24.382; 24.383; 24.384; 24.229 | Samsung, Ricky Kaura | ricky.kaura@samsung.com | Rel-13 | 69 |  |  |  |  |  |
| 3619 | 1433.9.1.1 | Call Control – On Network |  | 135d? | 2015-09-07 A | 2016-03-11 A | 100% |  |  |  | finish no earlier than 2016-03-11 | C1 | 1080h | 1080h | MCPTT-CT | 35 | 24.379 | Samsung, Ricky Kaura | ricky.kaura@samsung.com | Rel-13 | 69 |  |  |  |  |  |
| 3620 | 1433.9.1.2 | Call Control – Off Network |  | 135d? | 2015-09-07 A | 2016-03-11 A | 100% |  |  |  | finish no earlier than 2016-03-11 | C1 | 1080h | 1080h | MCPTT-CT | 35 | 24.379 | Samsung, Ricky Kaura | ricky.kaura@samsung.com | Rel-13 | 69 |  |  |  |  |  |
| 3621 | 1433.9.1.3 | Floor Control – On Network |  | 135d? | 2015-09-07 A | 2016-03-11 A | 100% |  |  |  | finish no earlier than 2016-03-11 | C1 | 1080h | 1080h | MCPTT-CT | 35 | 24.380 | Samsung, Ricky Kaura | ricky.kaura@samsung.com | Rel-13 | 69 |  |  |  |  |  |
| 3622 | 1433.9.1.4 | Floor Control – Off Network |  | 135d? | 2015-09-07 A | 2016-03-11 A | 100% |  |  |  | finish no earlier than 2016-03-11 | C1 | 1080h | 1080h | MCPTT-CT | 35 | 24.380 | Samsung, Ricky Kaura | ricky.kaura@samsung.com | Rel-13 | 69 |  |  |  |  |  |
| 3623 | 1433.9.1.5 | Broadcast – Call Control and Floor Control |  | 135d? | 2015-09-07 A | 2016-03-11 A | 100% |  |  |  | finish no earlier than 2016-03-11 | C1 | 1080h | 1080h | MCPTT-CT | 35 | 24.379; 24.380 | Samsung, Ricky Kaura | ricky.kaura@samsung.com | Rel-13 | 69 |  |  |  |  |  |
| 3624 | 1433.9.1.6 | Group management |  | 135d? | 2015-09-07 A | 2016-03-11 A | 100% |  |  |  | finish no earlier than 2016-03-11 | C1 | 1080h | 1080h | MCPTT-CT | 35 | 24.381 | Samsung, Ricky Kaura | ricky.kaura@samsung.com | Rel-13 | 69 |  |  |  |  |  |
| 3625 | 1433.9.1.7 | Identity management |  | 135d? | 2015-09-07 A | 2016-03-11 A | 100% |  |  |  | finish no earlier than 2016-03-11 | C1 | 1080h | 1080h | MCPTT-CT | 35 | 24.382 | Samsung, Ricky Kaura | ricky.kaura@samsung.com | Rel-13 | 69 |  |  |  |  |  |
| 3626 | 1433.9.1.8 | Management Object |  | 135d? | 2015-09-07 A | 2016-03-11 A | 100% |  |  |  | finish no earlier than 2016-03-11 | C1 | 1080h | 1080h | MCPTT-CT | 35 | 24.383 | Samsung, Ricky Kaura | ricky.kaura@samsung.com | Rel-13 | 69 |  |  |  |  |  |
| 3627 | 1433.9.1.9 | Configuration management |  | 135d? | 2015-09-07 A | 2016-03-11 A | 100% |  |  |  | start no earlier than 2015-09-07 | C1 | 1080h | 1080h | MCPTT-CT | 36 | 24.384 | Samsung, Ricky Kaura | ricky.kaura@samsung.com | Rel-13 | 71 |  |  |  |  |  |
| 3628 | 1433.9.2 | CT3 aspects for MCPTT protocol aspects |  | 135d? | 2015-09-07 A | 2016-03-11 A | 100% |  |  |  | finish no earlier than 2016-03-11 | C3 | 1080h | 1080h | MCPTT-CT | 35 | 29.165 | Alcatel-Lucent, Keith Drage | keith.drage@alcatel-lucent.com | Rel-13 | 69 |  |  |  |  |  |
| 3629 | 1433.9.3 | CT4 aspects for MCPTT protocol aspects |  | 135d? | 2015-09-07 A | 2016-03-11 A | 100% |  |  |  | finish no earlier than 2016-03-11 | C4 | 1080h | 1080h | MCPTT-CT | 35 | 23.003; 23.008; 29.283 | Alcatel-Lucent, Keith Drage | keith.drage@alcatel-lucent.com | Rel-13 | 69 |  |  |  |  |  |
| 3630 | 1433.9.4 | CT6 aspects for MCPTT protocol aspects |  | 135d? | 2015-09-07 A | 2016-03-11 A | 100% |  |  |  | finish no earlier than 2016-03-11 | C6 | 1080h | 1080h | MCPTT-CT | 36 | 31.102; 31.103 | Alcatel-Lucent, Keith Drage | keith.drage@alcatel-lucent.com | Rel-13 | 70 |  |  |  |  |  |
| 3631 | 1433.9.5 | (IETF) IANA Registration of New SIP Resource- Priority Namespace for MCPTT |  | 103d? | 2016-02-10 A | 2016-06-30 A | 100% |  |  |  | start no earlier than 2016-02-10 | C1-IETF | 824h | 824h | MCPTT-CT | 36 | draft-holmberg-dispatch-mcptt-rp-namespace | Ericsson | christer.holmberg@ericsson.com | Rel-13 | 71 |  |  |  |  |  |
| 3632 | 1433.9.6 | (IETF) OAuth 2.0 Token Exchange (draft-ietf-oauth-token-exchange) --> RFC 8693 |  | 103d? | 2016-02-10 A | 2016-06-30 A | 100% |  |  |  | start no earlier than 2016-02-10 | C1-IETF | 824h | 824h | MCPTT-CT | 44 |  |  |  | Rel-13 | 87 |  |  |  |  |  |
| 3633 | 1433.10 | IMS Profile to support MCPTT |  | 130d? | 2015-09-14 A | 2016-03-11 A | 100% |  |  |  | finish no earlier than 2016-03-11 | C1 | 1040h | 1040h | MCPTT-Prof | 35 | 24.980 | Huawei, PATEL Milan | Milan.Patel@huawei.com | Rel-13 | 69 |  |  |  |  |  |
| 3634 | 1433.11 | UE Conformance Test Aspects - Support for Mission Critical Push To Talk over LTE (MCPTT) |  | 392d? | 2016-12-15 A | 2018-06-15 A | 100% |  |  |  | finish no earlier than 2018-06-15 | R5 | 3136h | 3136h | MCPTT-ConTest | 38 | 36.579-5 | US Department of Commerce |  | Rel-13 | 74 |  |  |  |  |  |
| 3635 | 1433.12 | Deleted: SA2 aspects for MCPTT |  | 1d? | 2015-03-13 A | 2015-03-13 A | 100% | 2014-06-18 | 2015-06-17 | 261d? | finish no earlier than 2015-03-13 | S2 | 8h | 8h | MCPTT | 33 | New 23.179 | Randy Bloomfield (randy@its.bldrdoc.gov) | Randy Bloomfield (randy@its.bldrdoc.gov) | Rel-13 | 64 |  | Public Safety (A-A) |  |  | SP-69 |
| 3636 | 1433.13 | Deleted (duplicated): Application Architecture to support MCPTT | milestone | 0d? | 2015-03-13 A | 2015-03-13 A | 100% |  |  |  | finish no earlier than 2015-03-13 | S6 |  |  | MCPTT | 34 |  | U.S. Department of Commerce | Randy Bloomfield (randy@its.bldrdoc.gov) | Rel-13 | 67 |  |  |  |  | SP-69 |
| 3637 | 1433.14 | Deleted (duplicated): SA6 aspects for MCPTT |  | 261d? | 2014-12-12 A | 2015-12-11 A | 100% |  |  |  | finish no earlier than 2015-12-11 | S6 | 2088h | 2088h | MCPTT | 34 |  | David Cypher (david.cypher at nist.gov) | David Cypher (david.cypher at nist.gov) | Rel-13 | 66 |  |  |  |  | SP-69 |

Notes:
- 3600: 7/12/15: 60%->85¦2/3/16: 85%->95¦7/6/17: 95%->100
- 3601: 2/3/16: 35%->65¦9/6/16: 65%->100
- 3602: 2/3/16: 15%->60¦9/6/16: 60%->95¦7/6/17: 95%->100
- 3603: 2/3/16: 40%->75¦9/6/16: 75%->100
- 3604: 2/3/16: 30%->60¦19/9/16: 60%->100
- 3605: 28/1/16: 23.799 added¦Acronym corrected ("NexGen"->"NextGen")¦7/3/16: 5%->15¦10/3/16: WID:SP-150853->SP-160200. Name changed from "Study on Architecture for next Generation System"¦9/6/16: 15%->35¦19/9/16: 35%->64¦22/9/16: WID:SP-160227->SP-16072
- 3606: includes RAN TR 38.801¦1/7/16: Compl:0%->10%¦1/7/16: CD:Thu 15/06/17->Wed 15/03/17¦1/7/16: WID: RP-160671->RP-161214¦1/7/16: Release: Rel-15->Rel-14¦28/7/16: 38.802 added¦26/9/16: Compl:10%->20%¦26/9/16: WID: RP-161214->RP-161596. 2/12/16: Moved
- 3607: -
- 3608: SP#65 updated WID SP-140276=>SP-140435. Mar 15: WID: SP-140879->SP-150164. 4/15: S4 added. 6/15: WID updated
- 3609: SP#65 completion 12/14=>06/15. Updated WID SP-140276=>SP-140435. Dec.14: 2->20%. Mar 15: WID: SP-140879->SP-150095. Mar15: 30%. Transferred to SA6. June 15: FCD shifted to Sept,WID updated¦June2015: Compl:24%->50¦June2015: Compl:50%->70. 3/8/15: Rapp
- 3610: Mar 2015: WID: SP-140879->SP-150164.¦June2015: Compl:0%->30, WID updated¦07/09/15: 30%->100, "To be confirmed" deleted, since SA2 has completed it.
- 3611: Mar 2015: WID: SP-140879->SP-150164. Name clarified.6/15: WID updated¦7/12/15: 0%->75¦10/12/15: FCD->March, ES in SP-150729¦7/3/16: 75%->80¦28/7/16: 33.280 added¦28/7/16: 39.880 added¦1/12/16: 80%->100
- 3612: Mar 2015: WID: SP-140879->SP-150164. Name clarified. 5/5/15: TR number added¦June2015: Compl:0%->5, WID updated¦Aug2015: 5%->15¦07/09/15: 15%->40¦7/12/15: 40%->80, FCD: 12/15->03/16¦7/3/16: 80%->85; 26/6/20: 85%->100
- 3613: SP#65 completion 09/14=>12/14. Exception in SP-140502. TS 22.179v100 for Information. Completed. Mar 15: WID: SP-140879->SP-150164. 6/15: WID updated
- 3614: June2015: added as per SP-150356¦June2015: Compl:0%->15. 31 July: Rapporteur corrected. 3/8/15: name aligned to the WID¦07/09/15: 15%->50¦07/09/15: 50%->85. 15/09/15: FCD: 09/15->12/15¦7/3/16: 85%->100
- 3615: Mar 2015: WID: SP-140879->SP-150164. Name clarified. FCD: 03/2016->12/2015¦June2015: Compl:5%->15, WID updated. 7/9/15: TS number added¦7/12/15: 15%->60. FCD -> 03/16, ES in SP-150729¦7/3/16: 60%->85¦1/12/16: 85%->98¦6/3/17: 98%->100
- 3616: Mar 2015: WID: SP-140879->SP-150164. Name clarified. FCD: 03/2016->12/2015¦June2015: Compl:0%->5, WID updated¦Aug2015: 5%->15¦07/09/15: 15%->40. ES in SP-150663¦7/3/16: 40%->85; 26/6/20: 85%->100
- 3617: 7/12/15: WID:CP-150587->CP-150793¦28/1/16: 24.384 added;
- 3618: 7/12/15: WID:CP-150587->CP-150793¦7/3/16: WID:CP-150863->CP-160160¦5/12/16: WID:CP-160160->CP-160817
- 3619: Proposed by Atle after some talks with several interested parties¦7/12/15: 0%->50¦7/12/15: WID:CP-150587->CP-150863. FCD->03/16, ES in CP-150721¦7/3/16: 50%->100¦7/3/16: WID:CP-150863->CP-160160¦5/12/16: WID:CP-160160->CP-160817
- 3620: Proposed by Atle after some talks with several interested parties¦7/12/15: 0%->75¦7/12/15: WID:CP-150587->CP-150863. FCD->03/16, ES in CP-150721¦7/3/16: 75%->100¦7/3/16: WID:CP-150863->CP-160160¦5/12/16: WID:CP-160160->CP-160817
- 3621: Proposed by Atle after some talks with several interested parties¦7/12/15: 0%->80¦7/12/15: WID:CP-150587->CP-150863. FCD->03/16, ES in CP-150721¦7/3/16: 80%->100¦7/3/16: WID:CP-150863->CP-160160¦5/12/16: WID:CP-160160->CP-160817
- 3622: Proposed by Atle after some talks with several interested parties¦7/12/15: 0%->85¦7/12/15: WID:CP-150587->CP-150863. FCD->03/16, ES in CP-150721¦7/3/16: 85%->100¦7/3/16: WID:CP-150863->CP-160160¦5/12/16: WID:CP-160160->CP-160817
- 3623: Proposed by Atle after some talks with several interested parties¦7/12/15: 0%->50¦7/12/15: WID:CP-150587->CP-150863. FCD->03/16, ES in CP-150721¦7/3/16: 50%->100¦7/3/16: WID:CP-150863->CP-160160¦5/12/16: WID:CP-160160->CP-160817
- 3624: Proposed by Atle after some talks with several interested parties¦7/12/15: 0%->75¦7/12/15: WID:CP-150587->CP-150863. FCD->03/16, ES in CP-150721¦7/3/16: 75%->100¦7/3/16: WID:CP-150863->CP-160160¦5/12/16: WID:CP-160160->CP-160817
- 3625: Proposed by Atle after some talks with several interested parties¦7/12/15: WID:CP-150587->CP-150863. FCD->03/16, ES in CP-150721¦7/3/16: 0%->100¦7/3/16: WID:CP-150863->CP-160160¦5/12/16: WID:CP-160160->CP-160817
- 3626: Proposed by Atle after some talks with several interested parties¦7/12/15: 0%->10¦7/12/15: WID:CP-150587->CP-150863. FCD->03/16, ES in CP-150721¦7/3/16: 10%->100. Name changed from "Configuration management"¦7/3/16: WID:CP-150863->CP-160160¦5/12/1
- 3627: Introduced from CT1 WP update in 03/16¦7/3/16: WID:CP-150863->CP-160160¦5/12/16: WID:CP-160160->CP-160817
- 3628: 7/12/15: 0%->70¦7/12/15: WID:CP-150587->CP-150863. FCD -> 03/16, ES in CP-150643¦7/3/16: 70%->100¦7/3/16: WID:CP-150863->CP-160160¦5/12/16: WID:CP-160160->CP-160817
- 3629: 7/12/15: WID:CP-150587->CP-150863. FCD -> 03/16, ES in CP-150864¦7/3/16: 0%->100¦7/3/16: WID:CP-150863->CP-160160¦5/12/16: WID:CP-160160->CP-160817
- 3630: 7/12/15: WID:CP-150587->CP-150863. FCD -> 03/16, ES in CP-150866¦7/3/16: 0%->100¦7/3/16: WID:CP-150863->CP-160160¦5/12/16: WID:CP-160160->CP-160817
- 3631: 5/12/16: WID:CP-160160->CP-160817
- 3633: 12/15: TR # added¦7/12/15: 0%->60¦7/12/15: WID:CP-150500->CP-150794. FCD -> 03/16, ES in CP-150722¦7/3/16: 60%->100
- 3634: 6/1/17: acronym changed from "MCPTT-UEConTest" ¦21/3/17: Compl:0%->5%¦21/3/17: 36.579-5 added;
- 3635: Mar 2015: transferred to SA6. Was 06/14 to 06/15. 6/15: WID updated
- 3636: Mar 2015: WID: SP-140879->SP-150164. Name clarified.6/15: WID updated. 7/15: removed since duplicates 640143 and 660054 (only 640143 is kept)
- 3637: Mar 2015: WID: SP-140879->SP-150164. Name clarified. 6/15: WID updated. 31 July: deleted since duplicates 640143 and 670031 (only 640143 is kept)

| ID | WBS | Task | Duration | Start | Finish | Complete | Baseline start | Baseline finish | Baseline duration | Constraint | Resources | Work | Actual work | Acronym | PCG approved | Impacted TSs and TRs | WI rapporteur name | WI rapporteur e-mail | Release | TSG approved | MCC resp | Status Report | Special Focus Doc | Acronym_3GU_Export |
| --- | --- | --- | --- | --- | --- | --- | --- | --- | --- | --- | --- | --- | --- | --- | --- | --- | --- | --- | --- | --- | --- | --- | --- | --- |
| 3638 | 1434 | **MBMS Extensions and Profiling** | 202d? | 2015-03-05 A | 2015-12-11 A | 100% |  |  |  |  | S4 | 4848h | 4848h | MEPRO | 34 | 26.346; new 26.852 | Imed Bouazizi, Samsung and Thorsten Lohmar, Ericsson | i.bouazizi@samsung.com, thorsten.lohmar@ericsson.com | Rel-13 | 67 |  |  |  |  |
| 3639 | 1434.1 | TR on Profiling and Extensions of MBMS | 202d? | 2015-03-05 A | 2015-12-11 A | 100% |  |  |  | finish no earlier than 2015-12-11 | S4 | 1616h | 1616h | MEPRO | 34 | new 26.852 | Imed Bouazizi, Samsung and Thorsten Lohmar, Ericsson | i.bouazizi@samsung.com, thorsten.lohmar@ericsson.com | Rel-13 | 67 |  |  |  |  |
| 3640 | 1434.2 | Specification of MBMS Extensions and Profiling | 202d? | 2015-03-05 A | 2015-12-11 A | 100% |  |  |  | start no earlier than 2015-03-05 | S4 | 1616h | 1616h | MEPRO | 34 | 26.346 | Imed Bouazizi, Samsung and Thorsten Lohmar, Ericsson | i.bouazizi@samsung.com, thorsten.lohmar@ericsson.com | Rel-13 | 67 |  |  |  |  |
| 3641 | 1435 | **Isolated E-UTRAN Operation for Public Safety** | 529d? | 2014-03-07 A | 2016-03-11 A | 100% | 2014-03-07 | 2014-09-17 | 139d? |  | S1 | 8600h | 8600h | IOPS | 32 | New 22.346 | General Dynamics | paul.piggin@gd-broadband.com | Rel-13 | 63 | Alain | S1-143304 | Public Safety (A-A) | IOPS |
| 3642 | 1435.1 | Stage 1 fo Isolated E-UTRAN Operation for Public Safety | 140d? | 2014-03-07 A | 2014-09-17 A | 100% | 2014-03-07 | 2014-09-17 | 139d? | finish no earlier than 2014-09-17 | S1 | 1120h | 1120h | IOPS | 32 | New 22.346 | General Dynamics | paul.piggin@gd-broadband.com | Rel-13 | 63 | Alain | S1-143304 | Public Safety (A-A) | IOPS |
| 3643 | 1435.2 | Stage 2 for Isolated E-UTRAN Operation for Public Safety | 140d? | 2015-06-18 A | 2015-12-30 A | 100% | 2014-03-07 | 2014-09-17 | 139d? | start no earlier than 2015-06-18 | S2 | 1120h | 1120h | IOPS | 32 | 23.401 | Phil Young | phil.young@gd-broadband.com | Rel-13 | 63 | Alain |  | Public Safety (A-A) | IOPS |
| 3644 | 1435.3 | Security aspects for Isolated E-UTRAN Operation for Public Safety | 76d? | 2015-09-16 A | 2015-12-30 A | 100% | 2014-03-07 | 2014-09-17 | 139d? | start no earlier than 2015-09-16 | S3 | 608h | 608h | IOPS | 32 | 33.401 | General Dynamics | paul.piggin@gd-ms.uk | Rel-13 | 63 | Alain |  | Public Safety (A-A) | IOPS |
| 3645 | 1435.4 | **CT aspects for IOPS** | 95d? | 2015-11-02 A | 2016-03-11 A | 100% |  |  |  |  | C6 | 1520h | 1520h | IOPS-CT | 36 |  | Heiko Kruse, Morpho Cards GmbH | heiko.kruse@mrpho.com | Rel-13 | 70 |  |  |  |  |
| 3646 | 1435.4.1 | CT6 aspects for IOPS | 95d? | 2015-11-02 A | 2016-03-11 A | 100% |  |  |  | finish no earlier than 2016-03-11 | C6 | 760h | 760h | IOPS-CT | 36 | 31.102 | Heiko Kruse, Morpho Cards GmbH | heiko.kruse@mrpho.com | Rel-13 | 70 |  |  |  |  |
| 3647 | 1436 | Service Requirements Maintenance for Group Communication System Enablers for LTE | 67d? | 2014-06-18 A | 2014-09-17 A | 100% | 2014-06-18 | 2014-09-17 | 66d? | finish no earlier than 2014-09-17 | S1 | 536h | 536h | SRM_GCSE_LTE | 33 | 22.468 | Nokia Networks | Juergen.Merkel@nsn.com | Rel-13 | 64 |  | S1-143307 | Public Safety (A-A) | SRM_GCSE_LTE |
| 3648 | 1437 | Enhanced Calling Information Presentation | 330d? | 2014-09-15 A | 2015-12-16 A | 100% | 2013-12-11 | 2014-09-17 | 201d? | finish no earlier than 2015-12-16 | S1 | 2640h | 2640h | ECIP | 32 | 22.182 (CAT); 22.183 (CRS) | China Mobile | LI Xiaofan (lixiaofan@chinamobile.com | Rel-13 | 62 | Alain | S1-143311 |  | ECIP |
| 3649 | 1438 | **Flexible Mobile Service Steering** | 392d? | 2014-09-15 A | 2016-03-11 A | 100% | 2013-12-11 | 2014-09-17 | 202d? |  | S1; S2 | 6367.76h | 6367.76h | FMSS | 33 | 22.101 | China Mobile | Lu Lu (lulu@chinamobile.com) | Rel-13 | 65 | Alain | S1-143310 |  | FMSS |
| 3650 | 1438.1 | Stage 1 for Flexible Mobile Service Steering | 3d? | 2014-09-15 A | 2014-09-17 A | 100% | 2013-12-11 | 2014-09-17 | 202d? | start no earlier than 2014-09-15 | S1 | 23.85h | 23.85h | FMSS-ST1 | 33 | 22.101 | China Mobile | Lu Lu (lulu@chinamobile.com) | Rel-13 | 65 | Alain | S1-143310 |  | FMSS |
| 3651 | 1438.2 | Flexible Mobile Service Steering TR Phase | 134d? | 2014-12-12 A | 2015-06-17 A | 100% |  |  |  | finish no earlier than 2015-06-17 | S2 | 1072h | 1072h | FMSS-SA2TR | 34 | 23.718 | Lu Lu, China Mobile | lulu@chinamobile.com | Rel-13 | 66 |  |  |  |  |
| 3652 | 1438.3 | Flexible Mobile Service Steering - Stage 2 | 134d? | 2014-12-12 A | 2015-06-17 A | 100% |  |  |  | start no earlier than 2014-12-12 | S2 | 1072h | 1072h | FMSS-SA2 | 34 |  | Lu Lu, China Mobile | lulu@chinamobile.com | Rel-13 | 66 |  |  |  |  |
| 3653 | 1438.4 | CT3 Aspect of Flexible Mobile Service Steering | 133d? | 2015-09-09 A | 2016-03-11 A | 100% |  |  |  | finish no earlier than 2016-03-11 | C3 | 1064h | 1064h | FMSS-CT | 35 | 29.abc; 29.212; 29.213 | ZTE,Zhou Xiaoyun | zhou.xiaoyun@zte.com.cn | Rel-13 | 69 |  |  |  |  |
| 3654 | 1439 | GERAN UTRAN Sharing Enhancements | 63d? | 2014-09-19 A | 2014-12-12 A | 100% |  |  |  | finish no earlier than 2014-12-12 | S1 | 504h | 504h | GUSH | 33 | 22.101 | Telefónica | chris.friel@telefonica.com | Rel-13 | 65 |  | SP-140515 |  | GUSH |
| 3655 | 1440 | **Application specific Congestion control for Data Communication** | 456d? | 2014-06-18 A | 2016-03-11 A | 100% | 2014-06-18 | 2014-09-17 | 66d? |  | S1; C1 | 14808h | 14808h | ACDC | 33 | 22.011 | NTT DOCOMO | Atsushi Minokuchi (minokuchi@nttdocomo.co.jp) | Rel-13 | 64 |  | S1-143305 |  | ACDC |
| 3656 | 1440.1 | Stage 1 for Application specific Congestion control for Data Communication | 67d? | 2014-06-18 A | 2014-09-17 A | 100% | 2014-06-18 | 2014-09-17 | 66d? | finish no earlier than 2014-09-17 | S1 | 536h | 536h | ACDC-ST1 | 33 | 22.011 | NTT DOCOMO | Atsushi Minokuchi (minokuchi@nttdocomo.co.jp) | Rel-13 | 64 |  | S1-143305 |  | ACDC |
| 3657 | 1440.2 | **Stage 3 for Application specific Congestion control for Data Communication** | 332d? | 2014-12-04 A | 2016-03-11 A | 100% |  |  |  |  | C1 | 7472h | 7472h | ACDC-CT | 34 | 24.105; 24.301; 24.008; 27.007; 31.102 | Kim, Jaehyun, LGE | jaehyun7.kim@lge.com | Rel-13 | 66 |  |  |  |  |
| 3658 | 1440.2.1 | CT1 part of Stage 3 for Application specific Congestion control for Data Communication | 270d? | 2014-12-04 A | 2015-12-16 A | 100% |  |  |  | finish no earlier than 2015-12-16 | C1 | 2160h | 2160h | ACDC-CT | 34 | 24.105; 24.301; 24.008; 27.007; 23.122 | Kim, Jaehyun, LGE | jaehyun7.kim@lge.com | Rel-13 | 66 |  |  |  |  |
| 3659 | 1440.2.2 | CT6 part of Stage 3 for Application specific Congestion control for Data Communication | 332d? | 2014-12-04 A | 2016-03-11 A | 100% |  |  |  | finish no earlier than 2016-03-11 | C6 | 2656h | 2656h | ACDC-CT | 34 | 31.102 | Kim, Jaehyun, LGE | jaehyun7.kim@lge.com | Rel-13 | 66 |  |  |  |  |
| 3660 | 1440.3 | **RAN aspects of Application specific Congestion control for Data Communication** | 197d? | 2015-03-16 A | 2015-12-15 A | 100% |  |  |  |  | R2 | 3152h | 3152h | ACDC-RAN | 34 |  | LG Electronics |  | Rel-13 | 67 |  |  |  |  |
| 3661 | 1440.3.1 | Core part: RAN aspects of Application specific Congestion control for Data Communication | 197d? | 2015-03-16 A | 2015-12-15 A | 100% |  |  |  | finish no earlier than 2015-12-15 | R2 | 1576h | 1576h | ACDC-RAN-Core | 34 |  | LG Electronics |  | Rel-13 | 67 |  | RP-151275 |  |  |

Notes:
- 3638: 1/4/15: TS number added¦14/09/15: WID:SP-150099->SP-150439
- 3639: 8/4/15: line added¦June2015: Compl:0%->10¦Aug2015: 10%->15¦07/09/15: 15%->40¦14/09/15: WID:SP-150099->SP-150439¦7/12/15: 40%->100
- 3640: 8/4/15: line added¦June2015: Compl:0%->10¦Aug2015: 10%->15¦07/09/15: 15%->40¦14/09/15: WID:SP-150099->SP-150439¦7/12/15: 40%->100
- 3641: SP#65 completed. TS 22.346v100 for 1-step Approval. Triggered by Rel-13 TR 22.897 (FS_IOPS)¦14/09/15: WID:SP 150358->SP-150463
- 3642: SP#65 completed. TS 22.346v100 for 1-step Approval. Triggered by Rel-13 TR 22.897 (FS_IOPS)¦14/09/15: WID:SP 150358->SP-150463
- 3643: 07/09/15: 0%->100¦14/09/15: WID:SP 150358->SP-150463
- 3644: 07/09/15: 0%->100¦11/12/15: 0%->100
- 3646: ES in CP-150837¦7/3/16: 0%->100
- 3647: SP#65 completed. Some Rel-12 service reqs have no Stage 2/3 implementation
- 3648: SP#65 approved WID & completed. Triggered by Rel-13 TR 22.810. Linked to Multimedia Telephony Service for IMS (UID_7038), Customized Alerting Tone (CAT) UID_370028, Customized Ringing Signal (CRS) UID_380067. 31/07/15: 100%
- 3649: SP#65 WID approved & completed. Triggered by Rel-13 TR 22.808 (FS_FMSS)
- 3650: SP#65 WID approved & completed. Triggered by Rel-13 TR 22.808 (FS_FMSS). Dec.14: moved from Feature to S1 BB
- 3651: 3/3: TR number added.Mar15: 15->20%¦June2015: Compl:20%->85¦07/09/15: 85%->100
- 3652: 07/09/15: 0%->90¦07/09/15: 90%->100
- 3653: 07/09/15: 0%->20¦14/09/15: WID:CP-150488->CP-150577¦7/12/15: 20%->90¦7/12/15: WID:CP-150577->CP-150799. FCD -> 03/16. ES in CP-150646¦7/3/16: 90%->100
- 3654: SP#65 exception in SP-140515. Triggered by TR 22.852 (FS_RSE and FS_GUSH). Completed.
- 3655: SP#65 completed. Triggered by Rel-13 Study TR 22.806
- 3656: Results from MCC Split of the SA1 feature into F+BB for stage 1
- 3657: Presented at CT#66. June 2015: FCD: June->Dec 2015, WID: CP-140999-> CP-150282
- 3658: Presented at CT#66¦June2015: Compl:0%->10. June 2015: FCD: June->Dec 2015, WID: CP-140999-> CP-150282¦07/09/15: 5%->70¦7/12/15: 70%->100
- 3659: Presented at CT#66. June 2015: FCD: June->Dec 2015, WID: CP-140999-> CP-150282. 12/15: FCD -> 03/16, ES in CP-150838¦7/3/16: 0%->100
- 3661: 03/07/15: Compl:0%->25% 03/07/15: WID: RP-150512->RP-150662 03/07/15: Stat Rep: ->RP-150661 29/09/15: Compl:25%->70% 29/09/15: Stat Rep: RP-150661->RP-151275¦1/1/16: Compl:70%->100%

| ID | WBS | Task | Duration | Start | Finish | Complete | Baseline start | Baseline finish | Baseline duration | Constraint | Resources | Work | Actual work | Acronym | PCG approved | WI rapporteur name | WI rapporteur e-mail | Release | TSG approved | MCC resp | Acronym_3GU_Export | PCG stopped | TSG stopped | Status Report |
| --- | --- | --- | --- | --- | --- | --- | --- | --- | --- | --- | --- | --- | --- | --- | --- | --- | --- | --- | --- | --- | --- | --- | --- | --- |
| 3662 | 1441 | **User Plane Congestion management** | 667d? | 2012-09-12 A | 2015-03-18 A | 100% | 2012-02-02 | 2015-06-17 | 890d? |  | S1; S2; C3; C4 | 39368h | 39368h | UPCON | 29 | KDDI | Eriko Yoshida (er-yoshida@kddi.com) | Rel-13 | 57 | Alain | UPCON |  |  |  |
| 3663 | 1441.1 | Stage 1 for User Plane Congestion management | 129d? | 2012-09-12 A | 2013-03-06 A | 100% | 2012-02-02 | 2013-03-06 | 289d? | start no earlier than 2012-09-12 | S1 | 1032h | 1032h | UPCON-ST1 | 29 | KDDI | Eriko Yoshida (er-yoshida@kddi.com) | Rel-13 | 57 | Alain |  |  |  |  |
| 3664 | 1441.2 | TR on Stage 2 for User Plane Congestion management | 595d? | 2012-12-12 A | 2015-03-18 A | 100% | 2012-12-12 | 2014-12-10 | 525d? | finish no earlier than 2015-03-18 | S2 | 4760h | 4760h | UPCON-SA2TR | 30 | Allot | Alla Goldner (agoldner@allot.com) | Rel-13 | 58 | Maurice |  |  |  |  |
| 3665 | 1441.3 | Deleted - Stage 2 for User Plane Congestion management | 261d? | 2012-12-19 A | 2013-12-11 A | 100% | 2012-12-19 | 2013-12-11 | 261d? | finish no earlier than 2013-12-11 | S2 | 2088h | 2088h | UPCON-SA2Del | 30 | NEC | andreas.maeder@neclab.eu | Rel-13 | 58 | Maurice |  | PCG-32 | SP-62 |  |
| 3666 | 1441.4 | **BB1: RAN Downlink Traffic Differentiation, Congestion Detection and Reporting** | 269d? | 2014-03-07 A | 2015-03-13 A | 100% | 2014-03-07 | 2015-06-17 | 334d? |  | S2 | 10048h | 10048h | UPCON-DOTCON | 32 | Allot | Alla Goldner (agoldner@allot.com) | Rel-13 | 63 | Maurice | UPCON-DOTCON |  |  |  |
| 3667 | 1441.4.1 | Stage 2 for RAN Downlink Traffic Differentiation, Congestion Detection and Reporting | 201d? | 2014-03-07 A | 2014-12-12 A | 100% | 2014-03-07 | 2015-06-17 | 334d? | finish no earlier than 2014-12-12 | S2 | 1608h | 1608h | UPCON-DOTCON-SA2 | 32 | Allot | Alla Goldner (agoldner@allot.com) | Rel-13 | 63 | Maurice |  |  |  |  |
| 3668 | 1441.4.2 | **CT aspects of User Plane Congestion Management for BB1** | 262d? | 2014-03-18 A | 2015-03-13 A | 100% |  |  |  |  | C3 | 6288h | 6288h | UPCON-DOTCON-CT | 33 | Huawei | Xia Haitao (xiahaitao@huawei.com) | Rel-13 | 65 |  | UPCON-DOTCON-CT |  |  |  |
| 3669 | 1441.4.2.1 | CT3 part of CT aspects of User Plane Congestion Management for BB1 | 262d? | 2014-03-18 A | 2015-03-13 A | 100% |  |  |  | finish no earlier than 2015-03-13 | C3 | 2096h | 2096h | UPCON-DOTCON-CT | 33 | Huawei | Xia Haitao (xiahaitao@huawei.com) | Rel-13 | 65 |  |  |  |  |  |
| 3670 | 1441.4.2.2 | CT4 part of CT aspects of User Plane Congestion Management for BB1 | 262d? | 2014-03-18 A | 2015-03-13 A | 100% |  |  |  | finish no earlier than 2015-03-13 | C4 | 2096h | 2096h | UPCON-DOTCON-CT | 33 | Huawei | Xia Haitao (xiahaitao@huawei.com) | Rel-13 | 65 |  |  |  |  |  |
| 3671 | 1441.5 | Deleted - BB2: Application and Content Prioritization | 140d? | 2014-03-07 A | 2014-09-17 A | 100% | 2014-03-07 | 2015-06-17 | 334d? | finish no earlier than 2014-09-17 | S2 | 1120h | 1120h | UPCON-CONDEL | 32 | Allot | Alla Goldner (agoldner@allot.com) | Rel-13 | 63 | Maurice | UPCON-CON | PCG-33 | SP-65 |  |
| 3672 | 1441.6 | Deleted - BB3: Uplink traffic and attended/unattended traffic | 140d? | 2014-03-07 A | 2014-09-17 A | 100% | 2014-03-07 | 2015-06-17 | 334d? | finish no earlier than 2014-09-17 | S2 | 1120h | 1120h | UPCON-TRAFDEL | 32 | Allot | Alla Goldner (agoldner@allot.com) | Rel-13 | 63 | Maurice | UPCON-TRAF | PCG-33 | SP-65 |  |
| 3673 | 1442 | **Media Handling Aspects of IMS-based Telepresence** | 660d? | 2014-09-09 A | 2017-03-15 A | 100% |  |  |  |  |  | 15416h | 15416h | IMS_TELEP_S4 | 33 | Intel | ozgur.oyman@intel.com | Rel-13 | 65 |  | IMS_TELEP_S4 |  |  |  |
| 3674 | 1442.1 | TR on Media Handling Aspects of IMS-based Telepresence | 269d? | 2014-09-09 A | 2015-09-16 A | 100% |  |  |  | finish no earlier than 2015-09-16 | S4 | 2152h | 2152h | IMS_TELEP_S4 | 33 | Intel | ozgur.oyman@intel.com | Rel-13 | 65 |  |  |  |  |  |
| 3675 | 1442.2 | Specification on Media Handling Aspects of IMS-based Telepresence | 334d? | 2014-09-09 A | 2015-12-16 A | 100% |  |  |  | finish no earlier than 2015-12-16 | S4 | 2672h | 2672h | IMS_TELEP_S4 | 33 | Intel | ozgur.oyman@intel.com | Rel-13 | 65 |  |  |  |  |  |
| 3676 | 1442.3 | (IETF) Protocol for Controlling Multiple Streams for Telepresence (CLUE) (draft-ietf-clue-protocol) | 331d? | 2015-12-10 A | 2017-03-15 A | 100% |  |  |  | finish no earlier than 2017-03-15 | S4-IETF | 2648h | 2648h | IMS_TELEP_S4 | 36 | Intel | ozgur.oyman@intel.com | Rel-13 | 71 |  |  |  |  |  |
| 3677 | 1442.4 | (IETF) Mapping RTP streams to CLUE media captures (draft-ietf-clue-rtp-mapping) | 331d? | 2015-12-10 A | 2017-03-15 A | 100% |  |  |  | finish no earlier than 2017-03-15 | S4-IETF | 2648h | 2648h | IMS_TELEP_S4 | 36 | Intel | ozgur.oyman@intel.com | Rel-13 | 71 |  |  |  |  |  |
| 3678 | 1442.5 | Deleted - (IETF) DTLS Encapsulation of SCTP Packets (draft-ietf-tsvwg-sctp-dtls-encaps) | 331d? | 2015-12-10 A | 2017-03-15 A | 100% |  |  |  | finish no earlier than 2017-03-15 | S4-IETF | 2648h | 2648h | IMS_TELEP_S4 | 36 | Intel | ozgur.oyman@intel.com | Rel-13 | 71 |  |  |  |  |  |
| 3679 | 1442.6 | (IETF) Using Simulcast in SDP and RTP Sessions (draft-ietf-mmusic-sdp-simulcast) | 331d? | 2015-12-10 A | 2017-03-15 A | 100% |  |  |  | finish no earlier than 2017-03-15 | S4-IETF | 2648h | 2648h | IMS_TELEP_S4 | 36 | Ericsson | tomas.frankkila@ericsson.com | Rel-13 | 71 |  |  |  |  |  |
| 3680 | 1443 | **RAN Sharing Enhancements** | 657d? | 2013-06-19 A | 2015-12-15 A | 100% | 2013-06-19 | 2013-12-11 | 129d? |  | S1; R3 | 16824h | 16824h | RSE | 31 | NEC | joerg.swetina@neclab.eu | Rel-13 | 60 | Alain | RSE |  |  |  |
| 3681 | 1443.1 | Stage 1 for RAN Sharing Enhancements | 129d? | 2013-06-19 A | 2013-12-11 A | 100% | 2013-06-19 | 2013-12-11 | 129d? |  | S1 | 1032h | 1032h | RSE-SA1 | 31 | NEC | joerg.swetina@neclab.eu | Rel-13 | 60 | Alain |  |  |  |  |
| 3682 | 1443.2 | **RAN aspects of RAN Sharing Enhancements for LTE** | 330d? | 2014-09-12 A | 2015-12-15 A | 100% | 2014-06-13 | 2015-06-12 | 261d? |  | R3 | 5280h | 5280h | RSE-RAN_LTE | 33 | NEC | Siva.Vakeesar@emea.nec.com | Rel-13 | 65 |  | RSE-RAN_LTE |  |  |  |
| 3683 | 1443.2.1 | Core part: RAN aspects of RAN Sharing Enhancements for LTE | 330d? | 2014-09-12 A | 2015-12-15 A | 100% | 2014-06-13 | 2015-06-12 | 261d? | finish no earlier than 2015-12-15 | R3 | 2640h | 2640h | RSE-RAN_LTE-Core | 33 | NEC | Siva.Vakeesar@emea.nec.com | Rel-13 | 65 |  | RSE-RAN_LTE-Core |  |  | RP-151295 |
| 3684 | 1444 | **Enhancements to WEBRTC interoperability** | 598d? | 2014-03-07 A | 2016-06-16 A | 100% | 2014-03-07 | 2015-06-17 | 334d? |  | S1; S2; S3 | 31200h | 31200h | eWebRTCi | 32 | Alcatel-Lucent | betsy.covell@alcatel-lucent.com | Rel-13 | 63 | Alain | eWebRTCi |  |  |  |
| 3685 | 1444.1 | Stage 1 for Enhancements to WEBRTC interoperability | 139d? | 2014-03-07 A | 2014-09-17 A | 100% | 2014-03-07 | 2014-09-17 | 139d? | finish no earlier than 2014-09-17 | S1 | 1112h | 1112h | eWebRTCi | 32 | Alcatel-Lucent | betsy.covell@alcatel-lucent.com | Rel-13 | 63 | Alain |  |  |  | S1-143303 |
| 3686 | 1444.2 | TR on Stage 2 for Enhancements to WEBRTC interoperability | 196d? | 2014-06-19 A | 2015-03-18 A | 100% | 2014-06-18 | 2015-03-18 | 196d? | finish no earlier than 2015-03-18 | S2 | 1568h | 1568h | eWebRTCi | 33 | China Mobile | Yu Qing (yuqing@chinamobile.com) | Rel-13 | 64 |  |  |  |  |  |
| 3687 | 1444.3 | Stage 2 for Enhancements to WEBRTC interoperability | 261d? | 2014-06-23 A | 2015-06-17 A | 100% | 2014-06-18 | 2015-06-17 | 261d? | finish no earlier than 2015-06-17 | S2 | 2088h | 2088h | eWebRTCi | 33 | China Mobile | Yu Qing (yuqing@chinamobile.com) | Rel-13 | 64 |  |  |  |  |  |
| 3688 | 1444.4 | TR on Security for Enhancements to WEBRTC interoperability | 273d? | 2014-09-17 A | 2015-09-30 A | 100% |  |  |  | start no earlier than 2014-09-17 | S3 | 2184h | 2184h | eWebRTCi | 33 | Ericsson | vesa.lehtovirta@ericsson.com | Rel-13 | 65 |  |  |  |  |  |
| 3689 | 1444.5 | Security for Enhancements to WEBRTC interoperability | 273d? | 2014-09-17 A | 2015-09-30 A | 100% |  |  |  | start no earlier than 2014-09-17 | S3 | 2184h | 2184h | eWebRTCi | 33 | Ericsson | vesa.lehtovirta@ericsson.com | Rel-13 | 65 |  |  |  |  |  |
| 3690 | 1444.6 | (IETF) Session Traversal Utilities for NAT (STUN) Extension for Third Party Authorization (draft-ietf-tram-turn-third-party-authz) | 198d? | 2014-09-17 A | 2015-08-12 A | 100% |  |  |  | start no earlier than 2014-09-17 | S3-IET | 1584h | 1584h | eWebRTCi | 35 | Alcatel-Lucent |  | Rel-13 | 69 |  |  |  |  |  |

Notes:
- 3662: SP#65 updated WID SP-140153=>SP-140631 (BBII & BBIII stopped). Triggered by Rel-12 TR 22.805 Study on User Plane Congestion management (FS_UPCON) / Impacted TSs and TRs: Stage 1/2/3
- 3663: SP#63 moved to Rel-13 updated WID SP-120890=>SP-140153. SP#59 completed. Convert TR 22.805 clause 6 consolidated requirements to normative requirements in 22.101. 3/3/15: start date corrected (was Mar 12) / Impacted TSs and TRs: 22.101
- 3664: SP#65 updated WID SP-140153=>SP-140631. TR 23.705v100 for Information. Dec.14: 87->98%. Mar15: 100% / Impacted TSs and TRs: new 23.705
- 3665: SP#62 stopped at 0% completion / Impacted TSs and TRs: TBD
- 3666: SP#65 updated WID SP-140153=>SP-140631. IncludES in CP-150RAN Congestion Detection: , RAN Traffic Differentiation, RAN Congestion Reporting, CN Congestion Mitigation mechanisms, Dynamic Policy Control
- 3667: SP#65 updated WID SP-140153=>S2-142850 (added impacted specs). Dec.14: 70->100% only if RAN agrees to standardize the FPI / Impacted TSs and TRs: 23.060; 23.203; 23.401
- 3668: Stage 3¦WID: CP-140734->CP-140929. June 2015: WID: CP-140929-> CP-150365. / Impacted TSs and TRs: Stage 3
- 3669: Dec.14: 0->60¦WID: CP-140734->CP-140929. Mar.15: 60->95%¦June2015: Compl:95%->100. WID: CP-140929-> CP-150365. / Impacted TSs and TRs: 29.201; 29.212; 29.213; 29.214; 29.215; 29.219; New 29.217 (PCC over Np)
- 3670: Dec.14: 0->20¦WID: CP-140734->CP-140929. Mar. 15: 50%¦June2015: Compl:50%->90. WID: CP-140929-> CP-150365.¦07/09/15: 90%->100 / Impacted TSs and TRs: 23.003; 29.303; New 29.405 (UPCON over Nq)
- 3671: SP#65 updated WID SP-140153=>SP-140631 (BBII & BBIII stopped). IncludES in CP-150Content specific UP prioritization (Video), Application specific UP prioritization / Impacted TSs and TRs: TBD
- 3672: SP#65 updated WID SP-140153=>SP-140631 (BBII & BBIII stopped). IncludES in CP-150Uplink Congestion Management, Un/Attended UE Information / Impacted TSs and TRs: TBD
- 3673: Can be seen as an "enhancement" of Rel-12 IMS-based Telepresence (IMS_TELEP) UID_530042. Mar. 15: 20%
- 3674: Dec.14: 0->10%. 8/4/15: 20%¦June2015: Compl:20%->30¦Aug2015: 30%->35¦07/09/15: 35%->60¦7/12/15: 60%->100 / Impacted TSs and TRs: New 26.9xy
- 3675: Dec.14: 0->10%. 8/4/15: 20%¦June2015: Compl:20%->30¦07/09/15: 30%->60¦7/12/15: 60%->100 / Impacted TSs and TRs: New 26.1xy
- 3676: 23/4/20: 60%->90. was (IETF) CLUE Protocol (draft-ietf-clue-protocol); 9/4/21: RFC 8847 added; / Impacted TSs and TRs: 26.22; RFC 8847
- 3677: 23/4/20: 60%->90; 9/4/21: RFC 8849 added; / Impacted TSs and TRs: 26.22; RFC 8849
- 3678: 22/3/18: 95%->100. 07/06/18: deleted as per SP-180260; 9/4/21: RFC 8261 added; / Impacted TSs and TRs: 26.22; RFC 8261
- 3679: 23/4/20: 60%->90; 9/4/21: RFC 8853 added; / Impacted TSs and TRs: 26.114; 26.223; RFC 8853
- 3680: Triggered by Rel-12 TR 22.852 Study on RAN Sharing Enhancements (FS_RSE)
- 3681: SP#62 completed / Impacted TSs and TRs: 22.101
- 3682: Triggered by TR 36.856 Study on RAN aspects of RAN Sharing Enhancements for LTE (FS_RSE-RAN_LTE) & SA1 22.101 Stage 1 / Impacted TSs and TRs: LTE
- 3683: ¦CD:Mon 15/06/15->Tue 15/09/15¦Stat Rep: -->RP-141891 1st Apr 15: Compl:15%->20% 1st Apr 15: Stat Rep: RP-141891->RP-150289 03/07/15: Compl:20%->75% 03/07/15: Stat Rep: RP-150289->RP-150875 29/09/15: Compl:75%->80% 29/09/15: CD:Tue 15/09/15->Tue 15/1 / Impacted TSs and TRs: 36.300; 36.413; 36.423
- 3684: SP#65 updated WID SP-14028=>SP-140630 (added SA3 part, SA1 change). Add enhanced interoperability support for WebRTC to Rel-12 Web Real Time Communication (WebRTC) Access to IMS. / Impacted TSs and TRs: Stage 1/2
- 3685: SP#65 completed. Updated WID SP-140286=>SP-140630 / Impacted TSs and TRs: 22.228
- 3686: SP#65 updated WID SP-14028=>SP-140630 (added SA3 part). Dec.14: 9->55%¦June2015: Compl:55%->85¦07/09/15: 85%->100 / Impacted TSs and TRs: New 23.706
- 3687: SP#65 updated WID SP-14028=>SP-140630 (added SA3 part)¦June2015: Compl:0%->85¦07/09/15: 85%->100 / Impacted TSs and TRs: 23.228
- 3688: SP#65 updated WID SP-14028=>SP-140630 (added SA3 part). Dec.14: 0->20%, TR number added. 3/3/15: 30%.¦June2015: Compl:30%->75¦11/12/15: 54%->100¦11/12/15: 100%->100 / Impacted TSs and TRs: New 33.872
- 3689: SP#65 updated WID SP-14028=>SP-140630 (added SA3 part). Dec.14: 0->20%¦11/12/15: 15%->100 / Impacted TSs and TRs: 33.203; 33.328
- 3690: TS 33.203 CR0235draft-ietf-tram-turn-third-party-authz¦7/3/16: 10%->100; 9/4/21: RFC 7635 added; / Impacted TSs and TRs: 33.203; RRC 7635 (was draft-ietf-tram-turn-third-party-authz); RFC 7635

| ID | WBS | Task | Type | Duration | Start | Finish | Complete | Baseline start | Baseline finish | Baseline duration | Constraint | Resources | Work | Actual work | Acronym | PCG approved | WI rapporteur name | WI rapporteur e-mail | Release | TSG approved | Impacted TSs and TRs | MCC resp | Acronym_3GU_Export | Special Focus Doc |
| --- | --- | --- | --- | --- | --- | --- | --- | --- | --- | --- | --- | --- | --- | --- | --- | --- | --- | --- | --- | --- | --- | --- | --- | --- |
| 3691 | 1444.7 | **Stage 3 for Enhancements to WebRTC interoperability** |  | 204d? | 2015-09-07 A | 2016-06-16 A | 100% |  |  |  |  | ct | 8808h | 8808h | eWebRTCi-CT | 35 | China Mobile, Song Yue | songyue@chinamobile.com | Rel-13 | 69 |  |  |  |  |
| 3692 | 1444.7.1 | CT1 aspects 3 for Enhancements to WebRTC interoperability |  | 75d? | 2015-09-07 A | 2015-12-18 A | 100% |  |  |  | finish no earlier than 2015-12-18 | C1 | 600h | 600h | eWebRTCi-CT | 35 | China Mobile, Song Yue | songyue@chinamobile.com | Rel-13 | 69 | 24.371; 24.229 |  |  |  |
| 3693 | 1444.7.2 | CT3 aspects for Enhancements to WebRTC interoperability |  | 135d? | 2015-09-07 A | 2016-03-11 A | 100% |  |  |  | finish no earlier than 2016-03-11 | C3 | 1080h | 1080h | eWebRTCi-CT | 35 | China Mobile, Song Yue | songyue@chinamobile.com | Rel-13 | 69 | 29.214 |  |  |  |
| 3694 | 1444.7.3 | CT4 aspects for Enhancements to WebRTC interoperability |  | 135d? | 2015-09-07 A | 2016-03-11 A | 100% |  |  |  | finish no earlier than 2016-03-11 | C4 | 1080h | 1080h | eWebRTCi-CT | 35 | China Mobile, Song Yue | songyue@chinamobile.com | Rel-13 | 69 | 29.228; 23.334; 29.334; 23.008 |  |  |  |
| 3695 | 1444.7.4 | (IETF) SDP-based Data Channel Negotiation (draft-ietf-mmusic-data-channel-sdpneg) |  | 69d? | 2015-12-08 A | 2016-03-11 A | 100% |  |  |  | finish no earlier than 2016-03-11 | C1-IETF; SA4-IETF | 1104h | 1104h | eWebRTCi-CT | 36 | Ericsson | christer.holmberg@ericsson.com | Rel-13 | 71 | 24.371; 24.229; RFC 8864 |  |  |  |
| 3696 | 1444.7.5 | (IETF) MSRP over Data Channels (draft-ietf-mmusic-msrp-usage-data-channel) |  | 69d? | 2015-12-08 A | 2016-03-11 A | 100% |  |  |  | start no earlier than 2015-12-08 | C1-IETF | 552h | 552h | eWebRTCi-CT | 36 | Ericsson | christer.holmberg@ericsson.com | Rel-13 | 71 | 24.371; 24.229; 26.223 |  |  |  |
| 3697 | 1444.7.6 | (IETF) A Language for Rules Describing JSON Content (draft-newton-json-content-rules) |  | 69d? | 2015-12-08 A | 2016-03-11 A | 100% |  |  |  | start no earlier than 2015-12-08 | C3-IETF | 552h | 552h | eWebRTCi-CT | 36 | Ericsson | christer.holmberg@ericsson.com | Rel-13 | 71 | 24.371; 24.229; 26.223 |  |  |  |
| 3698 | 1444.7.7 | Deleted - (IETF) Oauth 2.0 Proof-of-Possession (PoP) Security Architecture (draft-ietf-oauth-pop-architecture) |  | 138d? | 2015-12-08 A | 2016-06-16 A | 100% |  |  |  | start no earlier than 2015-12-08 | S3-IETF | 1104h | 1104h | eWebRTCi-CT | 44 |  |  | Rel-13 | 87 |  |  |  |  |
| 3699 | 1444.7.8 | (IETF) Session Traversal Utilities for NAT (STUN) Extension for Third-Party Authorization (draft-ietf-tram-turn-third-party-authz) --> RFC 7635 |  | 138d? | 2015-12-08 A | 2016-06-16 A | 100% |  |  |  | start no earlier than 2015-12-08 | S3-IETF | 1104h | 1104h | eWebRTCi-CT | 44 |  |  | Rel-13 | 87 |  |  |  |  |
| 3700 | 1445 | **Improvements to CS/PS coordination in UTRAN/GERAN Shared Networks** |  | 573d? | 2014-03-07 A | 2016-05-12 A | 100% | 2014-03-07 | 2014-12-10 | 199d? |  | S2 | 9768h | 9768h | CSPS_Coord | 32 | Ericsson | roland.gustafsson@ericsson.com | Rel-13 | 63 | Stage 2 | Maurice | CSPS_Coord |  |
| 3701 | 1445.1 | TR on Stage 2 for Improvements to CS/PS coordination in UTRAN/GERAN Shared Networks |  | 140d? | 2014-03-07 A | 2014-09-17 A | 100% | 2014-03-07 | 2014-12-10 | 199d? | finish no earlier than 2014-09-17 | S2 | 1120h | 1120h | CSPS_Coord-SA2TR | 32 | Ericsson | roland.gustafsson@ericsson.com | Rel-13 | 63 | New 23.704 | Maurice |  |  |
| 3702 | 1445.2 | Stage 2 for Improvements to CS/PS coordination in UTRAN/GERAN Shared Networks |  | 201d? | 2014-03-12 A | 2014-12-12 A | 100% | 2014-03-07 | 2014-12-10 | 199d? | finish no earlier than 2014-12-12 | S2 | 1608h | 1608h | CSPS_Coord-SA2 | 32 | Ericsson | roland.gustafsson@ericsson.com | Rel-13 | 63 | 23.216; 23.251; 23.272 | Maurice |  |  |
| 3703 | 1445.3 | RAN aspects for improvements to CS/PS coordination in GERAN Shared Networks |  | 307d? | 2015-03-11 A | 2016-05-12 A | 100% |  |  |  | finish no earlier than 2016-05-12 | G2 | 2456h | 2456h | CSPS_Coord_GERAN | 33 | Nicklas Johansson, Ericsson LM | Nicklas.Johansson@Ericsson.com | Rel-13 | 65 | 48.008; 48.018 |  |  |  |
| 3704 | 1446 | **Enhancements to Proximity-based Services** |  | 788d? | 2013-03-18 A | 2016-03-11 A | 100% | 2014-06-18 | 2015-06-12 | 258d? |  | S1; S2; S3 | 27152h | 27152h | eProSe | 33 | Qualcomm | Eddy Hall (edhall@qti.qualcomm.com) | Rel-13 | 64 | Stage 1/2 |  | eProSe | Public Safety (A-A) |
| 3705 | 1446.1 | Stage 1 for Enhancements to Proximity-based Services |  | 66d? | 2014-06-19 A | 2014-09-17 A | 100% | 2014-06-18 | 2014-09-17 | 66d? | finish no earlier than 2014-09-17 | S1 | 528h | 528h | eProSe-SA1 | 33 | Qualcomm | Eddy Hall (edhall@qti.qualcomm.com) | Rel-13 | 64 | 22.115; 22.278 |  |  | Public Safety (A-A) |
| 3706 | 1446.2 | Stage 2 for Enhancements to Proximity-based Services - Extensions |  | 326d? | 2014-06-23 A | 2015-09-16 A | 100% | 2014-06-18 | 2015-06-12 | 258d? | finish no earlier than 2015-09-16 | S2 | 2608h | 2608h | eProSe-Ext-SA2 | 33 | Qualcomm | Haris Zisimopoulos (harisz@qti.qualcomm.com) | Rel-13 | 64 | 23.303; TBD |  | eProSe-Ext | Public Safety (A-A) |
| 3707 | 1446.3 | TR on Stage 2 for Enhancements to Proximity-based Services - Extensions |  | 193d? | 2014-06-18 A | 2015-03-13 A | 100% | 2014-06-18 | 2015-03-13 | 193d? | finish no earlier than 2015-03-13 | S2 | 1544h | 1544h | eProSe-Ext-SA2TR | 33 | Qualcomm | Haris Zisimopoulos (harisz@qti.qualcomm.com) | Rel-13 | 64 | New 23.713 |  |  | Public Safety (A-A) |
| 3708 | 1446.4 | Security for Enhancements to Proximity-based Services - Extensions |  | 388d? | 2014-09-19 A | 2016-03-11 A | 100% |  |  |  | finish no earlier than 2016-03-11 | S3 | 3104h | 3104h | eProSe-Ext-SA3 | 33 | Qualcomm | Adrian Escott (aescott@qti.qualcomm.com) | Rel-13 | 65 | 33.303 |  |  | Public Safety (A-A) |
| 3709 | 1446.5 | **CT aspects of enhancements to Proximity-based** |  | 195d? | 2015-06-15 A | 2016-03-11 A | 100% |  |  |  |  | C1 | 7304h | 7304h | eProSe-Ext-CT | 35 | Lena Chaponniere | lguellec@qti.qualcomm.com | Rel-13 | 68 | 23.122; 24.301; 24.333; 24.334 |  |  |  |
| 3710 | 1446.5.1 | CT1 aspects of enhancements to Proximity-based |  | 195d? | 2015-06-15 A | 2016-03-11 A | 100% |  |  |  | finish no earlier than 2016-03-11 | C1 | 1560h | 1560h | eProSe-Ext-CT | 35 | Lena Chaponniere | lguellec@qti.qualcomm.com | Rel-13 | 68 | 29.343 |  |  |  |
| 3711 | 1446.5.2 | CT3 aspects of enhancements to Proximity-based |  | 133d? | 2015-06-15 A | 2015-12-16 A | 100% |  |  |  | start no earlier than 2015-06-15 | C3 | 1064h | 1064h | eProSe-Ext-CT | 35 | Lena Chaponniere | lguellec@qti.qualcomm.com | Rel-13 | 68 | 23.003; 23.008; 29.272; 29.344; 29.345 |  |  |  |
| 3712 | 1446.5.3 | CT4 aspects of enhancements to Proximity-based |  | 195d? | 2015-06-15 A | 2016-03-11 A | 100% |  |  |  | finish no earlier than 2016-03-11 | C4 | 1560h | 1560h | eProSe-Ext-CT | 35 | Lena Chaponniere | lguellec@qti.qualcomm.com | Rel-13 | 68 | 31.102; 31.111 |  |  |  |
| 3713 | 1446.5.4 | CT6 aspects of enhancements to Proximity-based |  | 195d? | 2015-06-15 A | 2016-03-11 A | 100% |  |  |  | finish no earlier than 2016-03-11 | C6 | 1560h | 1560h | eProSe-Ext-CT | 35 | Lena Chaponniere | lguellec@qti.qualcomm.com | Rel-13 | 68 | 31.102; 31.111 |  |  |  |
| 3714 | 1446.6 | Study on Security for Proximity-based Services |  | 596d? | 2013-03-18 A | 2015-06-17 A | 100% | 2013-03-07 | 2014-09-17 | 401d? | finish no earlier than 2015-06-17 | S3 | 4768h | 4768h | FS_ProSe_Sec | 30 | Qualcomm | Adrian Escott (aescott@qti.qualcomm.com) | Rel-13 | 59 | 33.833 | Mirko | FS_ProSe_Sec | Public Safety (A-A) |
| 3715 | 1446.7 | Note: Charging Aspects done in Rel-14 under CH14-Prose (UID 720049) | milestone | 0d? | 2015-06-17 A | 2015-06-17 A | 100% |  |  |  | start no earlier than 2015-06-17 | S5 |  |  | eProSe | 37 |  |  | Rel-13 | 72 |  |  |  |  |

Notes:
- 3691: 7/12/15: WID:CP-150498->CP-150790->CP-150767
- 3692: 7/12/15: 0%->100¦7/12/15: WID:CP-150498->CP-150790->CP-150767
- 3693: 7/12/15: WID:CP-150498->CP-150790->CP-150767. ES in CP-150644¦7/3/16: 0%->100
- 3694: 7/12/15: WID:CP-150498->CP-150790->CP-150767. ES in CP-150623¦7/3/16: 0%->100
- 3695: 7/3/16: Introduced by IETF updates; 23/4/20: 75%->90; 9/4/21: RFC 8864 added;
- 3696: 7/3/16: Introduced by IETF updates
- 3697: 7/3/16: Introduced by IETF updates. This individual draft will not further progress in IETF but is kept as reference in version -09; 23/4/20: 25%->100
- 3698: 9/4/21: 25%->100
- 3700: Provide improvements to the solutions for CS/PS coordination in TS 23.251 to ensure that CS/PS coordination can be achieved for all mobility scenarios
- 3701: SP#65 completed. TR 23.704v200 for Approval
- 3702: Dec.14: 0->100%
- 3703: June2015: Compl:0%->35¦07/09/15: 35%->50, FCD:08/15->11/15¦7/12/15: 50%->95, FCD: 12/15->02/16. 02/03/16: FCD: 02/16->05/16¦13/6/16: 95%->100
- 3704: -
- 3705: SP#65 completed. Some Rel-12 ProSe service requirements have not been implemented at Stage 2/3 level. These are taken up in Rel-13 Stage 2/3 and need Stage 1 appropriate service requirements. No new service requirements are introduced.
- 3706: SP#65 updated WID SP-140385=>SP-140573 (added SA3 part). Mar15: WID: SP-140573 ->SP-150028¦June2015: Compl:0%->30. FCD: June->Sept. 07/09/15: 24->70%¦07/09/15: 70%->90¦7/12/15: 90%->100
- 3707: SP#65 updated WID SP-140385=>SP-140573 (added SA3 part). Acronym corrected: eProSe-Ex-SA2TRt->eProSe-Ext-SA2TR. Mar15: 60% Mar15: WID: SP-140573 ->SP-150028¦June2015: Compl:60%->90¦07/09/15: 90%->95¦07/09/15: 95%->100
- 3708: SP#65 updated WID SP-140385=>SP-140573 (added SA3 part). Acronym corrected: eProSe-Ex-SA3t->eProSe-Ext-SA3. Mar15: WID: SP-140573 ->SP-150028¦7/12/15: 0%->75¦10/12/15: FCD ->03/16, ES in SP-150714¦7/3/16: 75%->100
- 3710: 07/09/15: 0%->40¦7/12/15: 40%->90. FCD -> 03/16, ES in CP-150724¦7/3/16: 90%->100
- 3711: 07/09/15: 0%->60¦8/3/16: 60%->100
- 3712: 07/09/15: 0%->10¦7/12/15: 10%->80. FCD->03/16. ES in CP-150616¦7/3/16: 80%->100
- 3713: 7/12/15: FCD -> 03/16, ES in CP-150839. FCD->03/16. ES in CP-150616¦7/3/16: 0%->95¦8/3/16: 95%->100
- 3714: SP#65 updated WID SP-140300=>SP-140629 (Moved the TR phase to Rel-13 as a stand-alone Study). Completion 09/14=>06/15. SP#64 TR 33.833 v100 for Information. 4/3/15: 95%->70% (more topics to be included)¦June2015: Compl:70%->75¦7/12/15: 75%->95¦7/3/1

| ID | WBS | Task | Duration | Start | Finish | Complete | Baseline start | Baseline finish | Baseline duration | Constraint | Resources | Work | Actual work | Acronym | PCG approved | WI rapporteur name | Release | TSG approved | Acronym_3GU_Export | TSG stopped |
| --- | --- | --- | --- | --- | --- | --- | --- | --- | --- | --- | --- | --- | --- | --- | --- | --- | --- | --- | --- | --- |
| 3716 | 1447 | **voice over E-UTRAN Paging Policy Differentiation** | 133d? | 2014-06-16 A | 2014-12-12 A | 100% | 2014-06-16 | 2014-12-10 | 128d? |  | S1; S2; C4; C1; C3 | 9244.75h | 9244.75h | voE_UTRAN_PPD | 33 | Alcatel-Lucent | Rel-13 | 64 | voE_UTRAN_PPD |  |
| 3717 | 1447.1 | Stage 1 for voice over E-UTRAN Paging Policy Differentiation | 3d? | 2014-06-16 A | 2014-06-18 A | 100% | 2014-06-16 | 2014-06-18 | 3d? | finish no earlier than 2014-06-18 | S1 | 24h | 24h | voE_UTRA-N_PPD-SA1 | 33 | Alcatel-Lucent | Rel-13 | 64 |  |  |
| 3718 | 1447.2 | Stage 2 for voice over E-UTRAN Paging Policy Differentiation | 128d? | 2014-06-18 A | 2014-12-12 A | 100% | 2014-06-18 | 2014-12-10 | 126d? | finish no earlier than 2014-12-12 | S2 | 1024h | 1024h | voE_UTRAN_PPD-SA2 | 33 | Alcatel-Lucent | Rel-13 | 64 |  |  |
| 3719 | 1447.3 | **CT aspects of voice over E-UTRAN Paging Policy Differentiation** | 63d? | 2014-09-16 A | 2014-12-09 A | 100% |  |  |  |  | C4; C1; C3 | 3024h | 3024h | voE_UTRAN_PPD-CT | 33 | Alcatel-Lucent | Rel-13 | 65 |  |  |
| 3720 | 1447.3.1 | CT4 part of CT aspects of voice over E-UTRAN Paging Policy Differentiation | 63d? | 2014-09-16 A | 2014-12-09 A | 100% |  |  |  | finish no earlier than 2014-12-09 | C4 | 504h | 504h | voE_UTRAN_PPD-CT | 33 | Alcatel-Lucent | Rel-13 | 65 |  |  |
| 3721 | 1447.3.2 | CT1 part of CT aspects of voice over E-UTRAN Paging Policy Differentiation | 63d? | 2014-09-16 A | 2014-12-09 A | 100% |  |  |  | finish no earlier than 2014-12-09 | C1 | 504h | 504h | voE_UTRAN_PPD-CT | 33 | Alcatel-Lucent | Rel-13 | 65 |  |  |
| 3722 | 1447.3.3 | CT3 part of CT aspects of voice over E-UTRAN Paging Policy Differentiation | 63d? | 2014-09-16 A | 2014-12-09 A | 100% |  |  |  | finish no earlier than 2014-12-09 | C3 | 504h | 504h | voE_UTRAN_PPD-CT | 33 | Alcatel-Lucent | Rel-13 | 65 |  |  |
| 3723 | 1448 | **IP Flow Mobility support for S2a and S2b Interfaces** | 524d? | 2014-06-18 A | 2016-06-15 A | 100% | 2014-06-18 | 2015-06-17 | 261d? |  | S2 | 15656h | 15656h | NBIFOM | 33 | Tricci So, ZTE | Rel-13 | 64 | NBIFOM |  |
| 3724 | 1448.1 | TR for IP Flow Mobility support for S2a and S2b Interfaces | 193d? | 2014-06-18 A | 2015-03-13 A | 100% | 2014-06-18 | 2015-03-13 | 193d? | finish no earlier than 2015-03-13 | S2 | 1544h | 1544h | NBIFOM-SA2TR | 33 | Tricci So, ZTE | Rel-13 | 64 |  |  |
| 3725 | 1448.2 | Stage 2 for IP Flow Mobility support for S2a and S2b Interfaces | 326d? | 2014-06-23 A | 2015-09-16 A | 100% | 2014-06-18 | 2015-06-17 | 261d? | finish no earlier than 2015-09-16 | S2 | 2608h | 2608h | NBIFOM-SA2 | 33 | Tricci So, ZTE | Rel-13 | 64 |  |  |
| 3726 | 1448.3 | Charging Aspects of IP Flow Mobility support for S2a and S2b Interfaces (NBIFOM) | 196d? | 2015-09-16 A | 2016-06-15 A | 100% | 2014-06-18 | 2015-06-17 | 261d? | finish no earlier than 2016-06-15 | S5 | 1568h | 1568h | NBIFOM-CH | 35 | GUO Wenjie, ZTE | Rel-13 | 69 |  |  |
| 3727 | 1448.4 | **CT aspects of IP Flow Mobility support for S2a and S2b Interfaces** | 195d? | 2015-06-15 A | 2016-03-11 A | 100% |  |  |  |  | C1 | 5744h | 5744h | NBIFOM-CT | 35 | Xingyue(Joy) Zhou, ZTECorporation | Rel-13 | 68 |  |  |
| 3728 | 1448.4.1 | CT1 aspects of IP Flow Mobility support for S2a and S2b Interfaces | 195d? | 2015-06-15 A | 2016-03-11 A | 100% |  |  |  | finish no earlier than 2016-03-11 | C1 | 1560h | 1560h | NBIFOM-CT | 35 | Xingyue(Joy) Zhou, ZTECorporation. ES in 641 | Rel-13 | 68 |  |  |
| 3729 | 1448.4.2 | CT3 aspects of IP Flow Mobility support for S2a and S2b Interfaces | 195d? | 2015-06-15 A | 2016-03-11 A | 100% |  |  |  | finish no earlier than 2016-03-11 | C3 | 1560h | 1560h | NBIFOM-CT | 35 | 680001Xingyue(Joy) Zhou, ZTECorporation. ES in 641 | Rel-13 | 68 |  |  |
| 3730 | 1448.4.3 | CT4 aspects of IP Flow Mobility support for S2a and S2b Interfaces | 133d? | 2015-06-15 A | 2015-12-16 A | 100% |  |  |  | start no earlier than 2015-06-15 | C4 | 1064h | 1064h | NBIFOM-CT | 35 | Xingyue(Joy) Zhou, ZTECorporation | Rel-13 | 68 |  |  |
| 3731 | 1449 | **Double Resource Reuse for Multiple Media Sessions** | 264d? | 2014-03-14 A | 2015-03-13 A | 100% | 2014-03-14 | 2015-03-13 | 261d? |  | S2 | 5952h | 5952h | DRuMS | 33 | Ericsson | Rel-13 | 64 | DRuMS |  |
| 3732 | 1449.1 | Stage 2 for Double Resource Reuse for Multiple Media Sessions | 264d? | 2014-03-14 A | 2015-03-13 A | 100% | 2014-03-14 | 2015-03-13 | 261d? | finish no earlier than 2015-03-13 | S2 | 2088h | 2088h | DRuMS-SA2 | 33 | Ericsson | Rel-13 | 64 |  |  |
| 3733 | 1449.2 | **CT aspects of Double Resource Reuse for Multiple Media Sessions** | 73d? | 2014-12-03 A | 2015-03-13 A | 100% |  |  |  |  | C3 | 1752h | 1752h | DRuMS-CT | 34 | Ericsson | Rel-13 | 66 |  |  |
| 3734 | 1449.2.1 | CT1 aspects of Double Resource Reuse for Multiple Media Sessions | 73d? | 2014-12-03 A | 2015-03-13 A | 100% |  |  |  | start no earlier than 2014-12-03 | C1 | 584h | 584h | DRuMS-CT | 34 | Ericsson | Rel-13 | 66 |  |  |
| 3735 | 1449.2.2 | CT3 aspects of Double Resource Reuse for Multiple Media Sessions | 73d? | 2014-12-03 A | 2015-03-13 A | 100% |  |  |  | start no earlier than 2014-12-03 | C3 | 584h | 584h | DRuMS-CT | 34 | Ericsson | Rel-13 | 66 |  |  |
| 3736 | 1450 | Lawful Interception in the 3GPP Rel-13 | 656d? | 2014-06-18 A | 2016-12-15 A | 100% | 2014-06-18 | 2015-12-09 | 386d? | finish no earlier than 2016-12-15 | S3 | 5248h | 5248h | LI13 | 33 | PIDS, Alcatel-Lucent | Rel-13 | 64 | LI13 |  |
| 3737 | 1451 | STOPPED - Study on Lawful Interception Service Evolution | 386d? | 2014-06-23 A | 2015-12-09 A | 100% | 2014-06-18 | 2015-12-09 | 386d? | finish no earlier than 2015-12-09 | S3 | 3088h | 3088h | FS_LISE | 33 | Alcatel-Lucent | Rel-13 | 64 | FS_LISE | 80 |
| 3738 | 1452 | **Video enhancements by Region-Of-Interest information signalling** | 394d? | 2014-06-18 A | 2015-12-16 A | 100% | 2014-06-18 | 2015-06-17 | 261d? |  | S4 | 10016h | 10016h | ROI | 33 | Intel | Rel-13 | 64 | ROI |  |
| 3739 | 1452.1 | SA4 aspects of Video enhancements by Region-Of-Interest information signalling | 329d? | 2014-06-18 A | 2015-09-16 A | 100% |  |  |  | finish no earlier than 2015-09-16 | S4 | 2632h | 2632h | ROI | 33 | Intel | Rel-13 | 64 |  |  |

Notes:
- 3716: - / Impacted TSs and TRs: Stage 1/2 / WI rapporteur e-mail: (betsy.covell@alcatel-lucent.com)
- 3717: SP#64 approved WID & completed / Impacted TSs and TRs: 22.228; 22.278 / WI rapporteur e-mail: betsy.covell@alcatel-lucent.com
- 3718: Architectural enhancements allowing a differentiated paging policy for IMS voice calls over E-UTRAN. Dec.14: 25->100% / Impacted TSs and TRs: 23.228; 23.401 / WI rapporteur e-mail: laurent.thiebaut@alcatel-lucent.com
- 3719: Stage 3 / Impacted TSs and TRs: Stage 3 / WI rapporteur e-mail: bruno.landais@alcatel-lucent.com
- 3720: Mar.15: 0->100% / Impacted TSs and TRs: 29.274; 29.281 / WI rapporteur e-mail: bruno.landais@alcatel-lucent.com
- 3721: Dec.14: 0->50%¦07/09/15: 50%->50¦7/12/15: 50%->100 / Impacted TSs and TRs: 24.229 / WI rapporteur e-mail: bruno.landais@alcatel-lucent.com
- 3722: Mar.15: 0->100% / Impacted TSs and TRs: 29.061 / WI rapporteur e-mail: bruno.landais@alcatel-lucent.com
- 3723: 06/15: WID: SP-140279->SP-150250 / Impacted TSs and TRs: Stage 2 / WI rapporteur e-mail: tso@zte.com.cn
- 3724: Revived the Rel-12 DRAFT TR 23.861 stopped at SP#59 (at 40% completion). Dec.14: 20->60%¦June2015: Compl:60%->90, WID: SP-140279->SP-150250 / Impacted TSs and TRs: New 23.861 / WI rapporteur e-mail: tso@zte.com.cn
- 3725: June2015: Compl:0%->65, WID: SP-140279->SP-150250¦07/09/15: 52%->100 / Impacted TSs and TRs: 23.402; New 23.203 / WI rapporteur e-mail: tso@zte.com.cn
- 3726: 7/12/15: 0%->50. ES in SP-150710 (wrong UID mentioned in the ES)¦7/3/16: 50%->85%, FCD:03/16->06/16¦13/6/16: 85%->100 / Impacted TSs and TRs: 32.251; 32.298; 32.299 / WI rapporteur e-mail: guo.wenjie1@zte.com.cn
- 3727: 14/09/15: WID:CP-150285->CP-150497¦7/12/15: WID:CP-150497->CP-150791->874 / Impacted TSs and TRs: 24.161 / WI rapporteur e-mail: zhou.xingyue@zte.com.cn
- 3728: 07/09/15: 0%->25¦14/09/15: WID:CP-150285->CP-150497¦7/12/15: 25%->75¦7/12/15: WID:CP-150497->CP-150791->874. FCD -> 03/16. ES in CP-150725¦7/3/16: 75%->100 / Impacted TSs and TRs: 24.301; 24.302; 24.244; 24.008 / WI rapporteur e-mail: zhou.xingyue@zte.com.cn
- 3729: 07/09/15: 0%->40¦14/09/15: WID:CP-150285->CP-150497¦7/12/15: 40%->95¦7/12/15: WID:CP-150497->CP-150791->874. FCD -> 03/16. ES in CP-150725¦7/3/16: 95%->100 / Impacted TSs and TRs: 29.212; 29.213; 29.214; 29.215 / WI rapporteur e-mail: zhou.xingyue@zte.com.cn
- 3730: 07/09/15: 0%->20¦14/09/15: WID:CP-150285->CP-150497¦7/12/15: 20%->100¦7/12/15: WID:CP-150497->CP-150791->874 / Impacted TSs and TRs: 29.274; 23.008 / WI rapporteur e-mail: zhou.xingyue@zte.com.cn
- 3731: - / Impacted TSs and TRs: Stage 2 / WI rapporteur e-mail: George.Foti@ericsson.com
- 3732: Dec.14: 49->95%. Mar15: 100% / Impacted TSs and TRs: 23.203; 23.228 / WI rapporteur e-mail: George.Foti@ericsson.com
- 3733: Impacted TSs and TRs: 24.229; 24.615; 24.610; 24.605; 29.212; 29.213; 29.214; 29.215
- 3734: 5/5/15: C3 corrected in C1¦June2015: Compl:65%->90¦07/09/15: 90%->100 / Impacted TSs and TRs: 24.229; 24.615; 24.610; 24.605
- 3735: Mar.15: 65->95%¦June2015: Compl:95%->100 / Impacted TSs and TRs: 29.212; 29.213; 29.214; 29.215 / WI rapporteur e-mail: Jan Holm
- 3736: SP#65 updated WID SP-140400=>SP-140578. 2/4/15: WID SP-140815->SP-150111¦June2015: Compl:0%->10. WID: SP-150111->SP-150290¦14/09/15: WID:SP-150290->SP-150460¦7/12/15: 10%->15¦7/3/16: 13%->20¦7/3/16: WID:SP-150460->SP-160043¦19/9/16: 20%->60. FCD / Impacted TSs and TRs: 33.106; 33.107; 33.108 / WI rapporteur e-mail: Koen Jaspers (k.b.jaspers@minjus.nl), terry.jacobson@alcatel-lucent.com
- 3737: Linked to LI13 which defines existing LI service requirements in TS 33.106 as well as existing HI1, HI2 & HI3 reference points. 3/3/15: 0->5%¦7/12/15: 5%->10. Stoppped at 10% in March 2017.¦6/3/17: 10%->100 / Impacted TSs and TRs: 33.826 / WI rapporteur e-mail: terry.jacobson@alcatel-lucent.com
- 3738: Dec.14: 5->20%. Mar.15: 40%¦07/09/15: 43%->100 / Impacted TSs and TRs: 26.114 / WI rapporteur e-mail: ozgur.oyman@intel.com
- 3739: Created by MCC as the structure of the Feature get expanded to include CT aspects¦June2015: Compl:40%->90, FCD: 06/15->09/15¦Aug2015: Compl:90%->95 / Impacted TSs and TRs: 26.114 / WI rapporteur e-mail: ozgur.oyman@intel.com

| ID | WBS | Task | Duration | Start | Finish | Complete | Baseline start | Baseline finish | Baseline duration | Constraint | Resources | Work | Actual work | Acronym | PCG approved | WI rapporteur name | Release | TSG approved | Impacted TSs and TRs | Acronym_3GU_Export | Status Report | MCC resp |
| --- | --- | --- | --- | --- | --- | --- | --- | --- | --- | --- | --- | --- | --- | --- | --- | --- | --- | --- | --- | --- | --- | --- |
| 3740 | 1452.2 | **CT Aspects of Video Enhancements by Region-Of-Interest information signalling** | 133d? | 2015-06-15 A | 2015-12-16 A | 100% |  |  |  |  | C4 | 4256h | 4256h | ROI-CT | 35 | Vivek Gupta, Intel | Rel-13 | 68 |  |  |  |  |
| 3741 | 1452.2.1 | CT1 Aspects of Video Enhancements by Region-Of-Interest information signalling | 133d? | 2015-06-15 A | 2015-12-16 A | 100% |  |  |  | start no earlier than 2015-06-15 | C1 | 1064h | 1064h | ROI-CT | 35 | Vivek Gupta, Intel | Rel-13 | 68 | 24.229 |  |  |  |
| 3742 | 1452.2.2 | CT3 Aspects of Video Enhancements by Region-Of-Interest information signalling | 133d? | 2015-06-15 A | 2015-12-16 A | 100% |  |  |  | start no earlier than 2015-06-15 | C3 | 1064h | 1064h | ROI-CT | 35 | Vivek Gupta, Intel | Rel-13 | 68 | 29.162 |  |  |  |
| 3743 | 1452.2.3 | CT4 Aspects of Video Enhancements by Region-Of-Interest information signalling | 133d? | 2015-06-15 A | 2015-12-16 A | 100% |  |  |  | start no earlier than 2015-06-15 | C4 | 1064h | 1064h | ROI-CT | 35 | Vivek Gupta, Intel | Rel-13 | 68 | 23.334; 29.334; 29.238 |  |  |  |
| 3744 | 1453 | **TV video profile** | 396d? | 2014-09-09 A | 2016-03-11 A | 100% |  |  |  |  | S4 | 9504h | 9504h | TVProf | 33 | Orange | Rel-13 | 65 |  | TVProf |  |  |
| 3745 | 1453.1 | TR on TV video profile | 396d? | 2014-09-09 A | 2016-03-11 A | 100% |  |  |  | finish no earlier than 2016-03-11 | S4 | 3168h | 3168h | TVProf-SA4TR | 33 | Orange | Rel-13 | 65 | New 26.9xy; ES in SP-150650 |  |  |  |
| 3746 | 1453.2 | Specification on TV video profile | 396d? | 2014-09-09 A | 2016-03-11 A | 100% |  |  |  | finish no earlier than 2016-03-11 | S4 | 3168h | 3168h | TVProf-SA4 | 33 | Orange | Rel-13 | 65 | 26.234; 26.244; 26.346; 26.247; New 26.xyz; ES in SP-150650 |  |  |  |
| 3747 | 1454 | Enhanced LTE UE Delay test methods and requirements | 464d? | 2014-09-09 A | 2016-06-15 A | 100% |  |  |  | finish no earlier than 2016-06-15 | S4 | 3712h | 3712h | E_LTE_UED | 33 | Orange | Rel-13 | 65 | 26.131; 26.132 | E_LTE_UED |  |  |
| 3748 | 1455 | HTML5 Presentation Layer | 334d? | 2014-09-09 A | 2015-12-16 A | 100% |  |  |  | finish no earlier than 2015-12-16 | S4 | 2672h | 2672h | HTML5 | 33 | Samsung | Rel-13 | 65 | 26.140; 26.234; 26.247; 26.346; New 26.xyz | HTML5 |  |  |
| 3749 | 1456 | **Support of EVS in 3G Circuit-Switched networks** | 396d? | 2014-09-09 A | 2016-03-11 A | 100% |  |  |  |  | S4; C4; C1; C3; R1; R2; R3 | 24952h | 24952h | EVSoCS | 33 | Qualcomm | Rel-13 | 65 | 26.103; 28.062; New 26.454; New 26.453 | EVSoCS |  |  |
| 3750 | 1456.1 | SA4 aspects of EVS in 3G Circuit-Switched networks | 396d? | 2014-09-09 A | 2016-03-11 A | 100% |  |  |  | finish no earlier than 2016-03-11 | S4 | 3168h | 3168h | EVSoCS-S4 | 33 | Qualcomm | Rel-13 | 65 | 26.103; 28.062; New 26.454; New 26.453 | EVSoCS |  |  |
| 3751 | 1456.2 | **CT aspects of EVS in 3G Circuit-Switched Networks** | 268d? | 2015-03-04 A | 2016-03-11 A | 100% |  |  |  |  | C4; C1; C3 | 12344h | 12344h | EVSoCS-CT | 34 | Qualcomm, Lena Chaponniere | Rel-13 | 67 |  |  |  |  |
| 3752 | 1456.2.1 | CT1 aspects of EVS in 3G Circuit-Switched Networks | 203d? | 2015-03-04 A | 2015-12-11 A | 100% |  |  |  | finish no earlier than 2015-12-11 | C1 | 1624h | 1624h | EVSoCS-CT | 34 | Qualcomm, Lena Chaponniere | Rel-13 | 67 | 24.008 |  |  |  |
| 3753 | 1456.2.2 | CT3 aspects of EVS in 3G Circuit-Switched Networks | 268d? | 2015-03-04 A | 2016-03-11 A | 100% |  |  |  | finish no earlier than 2016-03-11 | C3 | 2144h | 2144h | EVSoCS-CT | 34 | Qualcomm, Lena Chaponniere | Rel-13 | 67 | 29.163; 29.414; 29.415 |  |  |  |
| 3754 | 1456.2.3 | CT4 aspects of EVS in 3G Circuit-Switched Networks | 268d? | 2015-03-04 A | 2016-03-11 A | 100% |  |  |  | finish no earlier than 2016-03-11 | C4 | 2144h | 2144h | EVSoCS-CT | 34 | Qualcomm, Lena Chaponniere | Rel-13 | 67 | 23.153; 23.334; 29.002; 29.231; 29.232; 29.332; 29.334 |  |  |  |
| 3755 | 1456.3 | **Support of EVS over UTRAN CS** | 130.67d? | 2015-06-16 A | 2015-12-15 A | 100% |  |  |  |  | R2; R1; R3 | 6272h | 6272h | EVSoCS_UTRAN | 34 | Qualcomm | Rel-13 | 66 |  |  |  |  |
| 3756 | 1456.3.1 | Core part: Support of EVS over UTRAN CS | 130.67d? | 2015-06-16 A | 2015-12-15 A | 100% |  |  |  | finish no earlier than 2015-12-15 | R2; R1; R3 | 3136h | 3136h | EVSoCS_UTRAN-Core | 34 | Francesco Pica - Qualcomm Incorporated | Rel-13 | 66 |  |  | RP-151282 |  |
| 3757 | 1457 | Enhanced DASH (Dynamic Adaptive Streaming over HTTP in 3GPP) | 334d? | 2014-09-09 A | 2015-12-16 A | 100% |  |  |  | finish no earlier than 2015-12-16 | S4 | 2672h | 2672h | eDASH | 33 | Qualcomm, Huawei | Rel-13 | 65 | 26.233; 26.234; 26.244; 26.247; 26.938; 26.346; 26.946 | eDASH |  |  |
| 3758 | 1458 | **QoS End-to-end Multimedia Telephony Service for IMS (MTSI) extensions (Stage 3)** | 796d? | 2013-03-06 A | 2016-03-11 A | 100% | 2013-03-06 | 2015-03-13 | 533d? |  | S4; C3; C1; C4 | 53457.8h | 53457.8h | QOSE2EMTSI | 30 | Ericsson | Rel-13 | 59 |  | QOSE2EMTSI |  | Paolo |
| 3759 | 1458.1 | TR on improved end-to-end QoS handling for MTSI | 589d? | 2013-12-11 A | 2016-03-11 A | 100% | 2013-12-11 | 2015-03-13 | 329d? | finish no earlier than 2016-03-11 | S4 | 4705.83h | 4705.83h | QOSE2EMTSI | 32 | Ericsson | Rel-13 | 62 | new 26.924 |  |  | Paolo |
| 3760 | 1458.2 | SA4 part of QoS End-to-end Multimedia Telephony Service for IMS (MTSI) extensions (Stage 3) | 792d? | 2013-03-06 A | 2016-03-11 A | 100% | 2013-03-06 | 2015-03-13 | 532d? | finish no earlier than 2016-03-11 | S4 | 6336h | 6336h | QOSE2EMTSI | 30 | Ericsson | Rel-13 | 59 | 26.114 |  |  | Paolo |
| 3761 | 1458.3 | **CT Aspects of QoS End-to-End MTSI Extensions** | 353d? | 2014-11-05 A | 2016-03-11 A | 100% |  |  |  |  | C3; C1; C4 | 16944h | 16944h | QOSE2EMTSI-CT | 34 | Ericsson | Rel-13 | 66 |  |  |  |  |
| 3762 | 1458.3.1 | CT3 Aspects of QoS End-to-End MTSI Extensions | 353d? | 2014-11-05 A | 2016-03-11 A | 100% |  |  |  | finish no earlier than 2016-03-11 | C3 | 2824h | 2824h | QOSE2EMTSI-CT | 34 | Ericsson | Rel-13 | 66 | 29.162; 29.163; 29.213; 29.214 |  |  |  |
| 3763 | 1458.3.2 | CT1 Aspects of QoS End-to-End MTSI Extensions | 353d? | 2014-11-05 A | 2016-03-11 A | 100% |  |  |  | finish no earlier than 2016-03-11 | C1 | 2824h | 2824h | QOSE2EMTSI-CT | 34 | Ericsson | Rel-13 | 66 | 24.229 |  |  |  |
| 3764 | 1458.3.3 | CT4 Aspects of QoS End-to-End MTSI Extensions | 353d? | 2014-11-05 A | 2016-03-11 A | 100% |  |  |  | finish no earlier than 2016-03-11 | C4 | 2824h | 2824h | QOSE2EMTSI-CT | 34 | Ericsson | Rel-13 | 66 | 23.333; 23.334; 29.238; 29.332; 29.333; 29.334 |  |  |  |

Notes:
- 3740: 14/09/15: WID:CP-150241->CP-150425 / WI rapporteur e-mail: vivek.g.gupta@intel.com
- 3741: 07/09/15: 100%->50¦14/09/15: WID:CP-150241->CP-150425¦7/12/15: 50%->100 / WI rapporteur e-mail: vivek.g.gupta@intel.com
- 3742: 07/09/15: 100%->10¦14/09/15: WID:CP-150241->CP-150425¦7/12/15: 10%->100 / WI rapporteur e-mail: vivek.g.gupta@intel.com
- 3743: 07/09/15: 100%->5¦14/09/15: WID:CP-150241->CP-150425¦7/12/15: 5%->100 / WI rapporteur e-mail: vivek.g.gupta@intel.com
- 3744: Mar. 15: 5->15% / WI rapporteur e-mail: gilles.teniou@orange.com
- 3745: Dec.14: 0->5%¦June2015: Compl:15%->30¦Aug2015: 30%->45¦07/09/15: 45%->70¦7/12/15: 70%->85, FCD: 12/15->03/16¦7/3/16: 85%->100 / WI rapporteur e-mail: gilles.teniou@orange.com
- 3746: Dec.14: 0->5%¦June2015: Compl:15%->30¦Aug2015: 30%->45¦07/09/15: 45%->70¦7/12/15: 70%->85, FCD: 12/15->03/16. ES in SP-150650¦7/3/16: 85%->100 / WI rapporteur e-mail: gilles.teniou@orange.com
- 3747: Mar. 15: 0->5%¦June2015: Compl:5%->10¦Aug2015: 10%->15¦07/09/15: 15%->50¦7/12/15: 50%->80, FCD: 12/15->03/16. ES in SP-150652¦7/3/16: FCD: 03/16->06/16¦11/6/16: 80%->100 / WI rapporteur e-mail: stephane.ragot@orange.com
- 3748: Triggered by Rel-12 TR 26.907 (Study of HTML5 and 3GPP User Services). Dec.14: 0->5%. Mar. 15: 10%¦June2015: Compl:10%->20¦Aug2015: 20%->40¦07/09/15: 40%->70¦7/12/15: 70%->100 / WI rapporteur e-mail: Imed Bouazizi (i.bouazizi@samsung.com)
- 3749: Provide CS support of EVS to enhance voice quality in CS services over UTRAN (3G WCDMA). Dec.14: 0->5%¦28/1/16: 26.454 added¦28/1/16: 26.453 added; / WI rapporteur e-mail: Imre Varga (ivarga@qti.qualcomm.com)
- 3750: Created by MCC (duplicated from previously single-line Feature) due to the introduction of the CT BB. Mar. 15: 10%¦Aug2015: 10%->20¦07/09/15: 20%->40¦7/12/15: 40%->60, FCD:12/15->03/16. ES in SP-150655¦28/1/16: 26.454 added¦28/1/16: 26.453 added; / WI rapporteur e-mail: Imre Varga (ivarga@qti.qualcomm.com)
- 3751: WI rapporteur e-mail: lguellec@qti.qualcomm.com
- 3752: 07/09/15: 0%->90¦7/12/15: 90%->100 / WI rapporteur e-mail: lguellec@qti.qualcomm.com
- 3753: June2015: Compl:0%->10¦07/09/15: 10%->15¦7/12/15: 15%->90. FCD -> 03/16, ES in CP-150638¦7/3/16: 90%->100 / WI rapporteur e-mail: lguellec@qti.qualcomm.com
- 3754: June2015: Compl:0%->95. FCD -> 03/16, ES in CP-150618¦7/3/16: 95%->100 / WI rapporteur e-mail: lguellec@qti.qualcomm.com
- 3755: WI rapporteur e-mail: Qualcomm
- 3756: Rapporteur details and involved WGs updated 1st Apr 15: Compl:0%->10% 1st Apr 15: Stat Rep: ->RP-150128. 5/5/15: 0->10% 03/07/15: Compl:10%->25% 03/07/15: Stat Rep: RP-150128->RP-150759 29/09/15: Compl:25%->50% 29/09/15: CD:Tue 15/09/15->Tue 15/12/15 2 / WI rapporteur e-mail: fpica@qti.qualcomm.com
- 3757: Triggered by Rel-12 Dec.14: 0->10%. Mar. 15: 15%¦June2015: Compl:15%->25. WID updated¦Aug2015: 25%->30¦07/09/15: 30%->60¦14/09/15: WID:SP-150211->SP-150448¦7/12/15: 60%->100 / WI rapporteur e-mail: Thomas Stockhammer (tsto@qti.qualcomm.com), Li Zhiming (lizhiming@huawei.com)
- 3758: SP#65 updated WID SP-130670=>SP-140601 (moved work from Rel-12 incl. new TR to Rel-13). Co-ordinate with SA2, CT1/3/4, IETF MMUSIC. Linked to SA4 Rel-7 Media handling and interaction in MTSI (MTSI-MHI) UID_7040 / WI rapporteur e-mail: tomas.frankkila@ericsson.com
- 3759: SP#65 updated WID SP-130670=>SP-140601 (moved work from Rel12 incl. new TR to Rel-13). Completion 03/15=>06/15. Mar15: 26.924 for info. 8/4/15: 50%¦Aug2015: 50%->60¦7/12/15: 75%->90, FCD: 06/15->03/16¦7/3/16: 90%->100 / WI rapporteur e-mail: tomas.frankkila@ericsson.com
- 3760: SP#65: WID SP-130670=>SP-140601 (moved from Rel12 incl. new TR to Rel-13). FCD 03/15=>06/15. St1 in TS 22.173. 12/14: 70->40%, CD: 06/15->09/15. 03/15: 50%. June 15: FCD: 09/15->12/15¦08/15: 60%¦09/15: 75%¦7/12. ES in SP-150658¦7/3/16: 90%->100 / WI rapporteur e-mail: tomas.frankkila@ericsson.com
- 3762: 7/12/15: 0%->70. FCD -> 03/16, ES in CP-150636¦7/3/16: 70%->100
- 3763: FCD -> 03/16, ES in CP-150726¦7/3/16: 0%->100
- 3764: FCD -> 03/16, ES in CP-150620¦7/3/16: 0%->100

| ID | WBS | Task | Duration | Start | Finish | Complete | Baseline start | Baseline finish | Baseline duration | Constraint | Resources | Work | Actual work | Acronym | PCG approved | Release | TSG approved | MCC resp | Special Focus Doc | Acronym_3GU_Export |
| --- | --- | --- | --- | --- | --- | --- | --- | --- | --- | --- | --- | --- | --- | --- | --- | --- | --- | --- | --- | --- |
| 3765 | 1459 | **MTSI Extension on Multi-stream Multiparty** | 322d? | 2014-12-12 A | 2016-03-07 A | 100% |  |  |  |  |  | 3176h | 3176h | MMCMH | 34 | Rel-13 | 66 |  |  |  |
| 3766 | 1459.1 | Codec aspects for MMCMH | 265d? | 2014-12-12 A | 2015-12-17 A | 100% |  |  |  | finish no earlier than 2015-12-17 | S4 | 2120h | 2120h | MMCMH | 34 | Rel-13 | 66 |  |  |  |
| 3767 | 1459.2 | (IETF) RTP Stream Pause and Resume (RFC 7728) | 66d? | 2015-12-07 A | 2016-03-07 A | 100% |  |  |  | finish no earlier than 2016-03-07 | S4-IETF | 528h | 528h | MMCMH | 36 | Rel-13 | 71 |  |  |  |
| 3768 | 1459.3 | (IETF) Using Simulcast in SDP and RTP Sessions (draft-ietf-mmusic-sdp-simulcast) | 66d? | 2015-12-07 A | 2016-03-07 A | 100% |  |  |  | start no earlier than 2015-12-07 | S4-IETF | 528h | 528h | MMCMH | 37 | Rel-13 | 72 |  |  |  |
| 3769 | 1460 | **Video Telephony Robustness Improvements Extensions** | 196d? | 2014-12-12 A | 2015-09-11 A | 100% |  |  |  |  | S4 | 6272h | 6272h | VTRI_EXT | 34 | Rel-13 | 66 |  |  |  |
| 3770 | 1460.1 | TR on Video Telephony Robustness Improvements | 196d? | 2014-12-12 A | 2015-09-11 A | 100% |  |  |  | finish no earlier than 2015-09-11 | S4 | 1568h | 1568h | VTRI_EXT | 34 | Rel-13 | 66 |  |  |  |
| 3771 | 1460.2 | Specification on Video Telephony Robustness Improvements | 196d? | 2014-12-12 A | 2015-09-11 A | 100% |  |  |  | finish no earlier than 2015-09-11 | S4 | 1568h | 1568h | VTRI_EXT | 34 | Rel-13 | 66 |  |  |  |
| 3772 | 1460.3 | (IETF) RTP Payload Format for Non-Interleaved and Interleaved Parity Forward Error Correction (FEC) (draft-ietf-payload-flexible-fec-scheme) --> RFC 8627 | 196d? | 2014-12-12 A | 2015-09-11 A | 100% |  |  |  | finish no earlier than 2015-09-11 | S4-IETF | 1568h | 1568h | VTRI_EXT | 35 | Rel-13 | 69 |  |  |  |
| 3773 | 1461 | Acoustic Test methods and Performance Objectives for Speakerphone Performance in Noisy Environments | 326d? | 2014-12-12 A | 2016-03-11 A | 100% |  |  |  | finish no earlier than 2016-03-11 | S4 | 2608h | 2608h | ATeMPO_SPINE | 34 | Rel-13 | 66 |  |  |  |
| 3774 | 1462 | **Rel-13 Operations, Administration, Maintenance and Provisioning (OAM&P)** | 985d? | 2012-06-20 A | 2016-03-11 A | 100% | 2014-09-17 | 2015-12-11 | 323d? |  | S5 | 57504h | 57504h | OAM13 | 32 | Rel-13 | 63 | Mirko | SON | OAM13 |
| 3775 | 1462.1 | Enhanced Network Management (NM) centralized Coverage and Capacity Optimization | 319d? | 2014-09-19 A | 2015-12-11 A | 100% | 2014-09-17 | 2015-12-11 | 319d? | finish no earlier than 2015-12-11 | S5 | 2552h | 2552h | SON-NM-CCO | 29 | Rel-13 | 56 | Mirko | SON | SON-NM-CCO |
| 3776 | 1462.2 | **Compliance of 3GPP SA5 specifications to the NGMN Top Operational Efficiency (OPE) Recommendations** | 728d? | 2012-06-20 A | 2015-03-18 A | 100% | 2012-06-20 | 2014-09-17 | 595d? |  | S5 | 17368h | 17368h | OAM-NGMN_OPE | 29 | Rel-13 | 56 | Mirko |  | OAM-NGMN_OPE |
| 3777 | 1462.2.1 | TR on Compliance of 3GPP SA5 specifications to the NGMN Top Operational Efficiency (OPE) Recommendations | 723d? | 2012-06-20 A | 2015-03-18 A | 100% | 2012-06-20 | 2014-09-17 | 593d? | finish no earlier than 2015-03-18 | S5 | 5784h | 5784h | OAM-NGMN_OPE | 29 | Rel-13 | 56 | Mirko |  |  |
| 3778 | 1462.2.2 | TS work on Compliance of 3GPP SA5 specifications to the NGMN Top Operational Efficiency (OPE) Recommendations | 720d? | 2012-06-25 A | 2015-03-18 A | 100% | 2012-06-25 | 2014-09-17 | 590d? | finish no earlier than 2015-03-18 | S5 | 5760h | 5760h | OAM-NGMN_OPE | 29 | Rel-13 | 56 | Mirko |  |  |
| 3779 | 1462.3 | Converged management Performance Management Interface Definitions | 910d? | 2012-06-20 A | 2015-12-11 A | 100% | 2012-06-20 | 2014-09-17 | 588d? | finish no earlier than 2015-12-11 | S5 | 7280h | 7280h | OAM-PMID | 29 | Rel-13 | 56 | Mirko |  | OAM-PMID |
| 3780 | 1462.4 | **WLAN Management** | 788d? | 2012-06-27 A | 2015-06-17 A | 100% | 2012-06-20 | 2014-09-17 | 595d? |  | S5 | 18848h | 18848h | WLAN-OAM | 29 | Rel-13 | 56 | Mirko | WLAN | WLAN-OAM |
| 3781 | 1462.4.1 | WLAN Network Resource Model for Type-2 interface | 784d? | 2012-06-27 A | 2015-06-17 A | 100% | 2012-06-27 | 2014-09-17 | 589d? | finish no earlier than 2015-06-17 | S5 | 6272h | 6272h | WLAN-OAM-SA5 | 29 | Rel-13 | 56 | Mirko | WLAN |  |
| 3782 | 1462.4.2 | WLAN measurements defined in IEEE and IETF WLAN performance measurements for use on Type-2 interface | 784d? | 2012-06-27 A | 2015-06-17 A | 100% | 2012-06-27 | 2014-09-17 | 589d? | finish no earlier than 2015-06-17 | S5 | 6272h | 6272h | WLAN-OAM-SA5ietf | 29 | Rel-13 | 56 | Mirko | WLAN |  |
| 3783 | 1462.5 | Energy Efficiency related Performance Measurements | 713d? | 2013-06-21 A | 2016-03-11 A | 100% | 2013-06-21 | 2014-09-17 | 326d? | finish no earlier than 2016-03-11 | S5 | 5704h | 5704h | OAM-PM_EE | 31 | Rel-13 | 60 | Mirko |  | OAM-PM_EE |
| 3784 | 1462.6 | Multi-Broadcast Single Frequency Network (MBSFN) Minimization of Drive Tests (MDT) enhancement | 1d? | 2014-12-12 A | 2014-12-12 A | 100% |  |  |  | start no earlier than 2014-12-12 | S5 | 8h | 8h | MBSFN_MDT | 34 | Rel-13 | 66 |  |  |  |
| 3785 | 1463 | **Rel-13 Charging** | 393d? | 2014-06-19 A | 2015-12-16 A | 100% | 2014-06-18 | 2015-12-09 | 386d? |  | S5 | 16236h | 16236h | CH13 | 33 | Rel-13 | 64 |  |  | CH13 |
| 3786 | 1463.1 | **Inter-PLMN PS domain online charging** | 393d? | 2014-06-19 A | 2015-12-16 A | 100% | 2014-06-18 | 2015-12-09 | 386d? |  | S5 | 8360h | 8360h | iPLMN-PS-OCH | 33 | Rel-13 | 64 |  |  | iPLMN-PS-OCH |
| 3787 | 1463.1.1 | TR on Inter-PLMN PS domain online charging | 261d? | 2014-06-19 A | 2015-06-17 A | 100% | 2014-06-18 | 2015-06-17 | 261d? | finish no earlier than 2015-06-17 | S5 | 2088h | 2088h | iPLMN-PS-OCH | 33 | Rel-13 | 64 |  |  |  |
| 3788 | 1463.1.2 | Specification of Inter-PLMN PS domain online charging | 391d? | 2014-06-23 A | 2015-12-16 A | 100% | 2014-06-18 | 2015-12-09 | 386d? | finish no earlier than 2015-12-16 | S5 | 3128h | 3128h | iPLMN-PS-OCH | 33 | Rel-13 | 64 |  |  |  |
| 3789 | 1463.2 | ULI and release causes for charging enhancement for VoLTE | 257d? | 2014-12-12 A | 2015-12-07 A | 100% |  |  |  | finish no earlier than 2015-12-07 | S5 | 2056h | 2056h | ULRELC-CH | 34 | Rel-13 | 66 |  |  |  |
| 3790 | 1463.3 | Charging on enhancements for IMS Service Continuity | 135d? | 2015-03-05 A | 2015-09-09 A | 100% |  |  |  | finish no earlier than 2015-12-11 | S5 | 1080h | 1080h | CHeISC | 34 | Rel-13 | 67 |  |  |  |
| 3791 | 1463.4 | Announcements for IMS Online Charging | 131d? | 2015-06-15 A | 2015-12-14 A | 100% |  |  |  | start no earlier than 2015-06-14 | S5 | 1048h | 1048h | ANIMO | 35 | Rel-13 | 68 |  |  |  |
| 3792 | 1463.5 | Enhanced S2a Mobility Over Trusted WLAN access to EPC - Charging | 68.5d? | 2015-06-15 A | 2015-09-17 A | 100% |  |  |  | start no earlier than 2015-06-15 | S5 | 548h | 548h | eSaMOG-CH | 35 | Rel-13 | 68 |  |  |  |

Notes:
- 3765: Mar. 15: 0->10%. WID: SP-140738->SP-150097¦June2015: Compl:10%->30¦Aug2015: 30%->50, FCD: sep->Dec 2015¦07/09/15: 50%->60¦7/12/15: 60%->100¦10/12/15: WID:SP-150097->SP-150660. Might be moved to Rel-14 (see note in UID710002) / Impacted TSs and TRs: 26.114; New 26.980 / WI rapporteur name: Tomas Frankkila, Ericsson LM / WI rapporteur e-mail: tomas.frankkila@ericsson.com
- 3766: Introduced by MCC to dissociate S4 from IeTF aspects / Impacted TSs and TRs: 26.114; New 26.980 / WI rapporteur name: Tomas Frankkila, Ericsson LM / WI rapporteur e-mail: tomas.frankkila@ericsson.com
- 3767: 02/2016: published as RFC 7728 / Impacted TSs and TRs: (IETF) RTP Stream Pause and Resume (RFC 7728) / WI rapporteur name: Ericsson / WI rapporteur e-mail: tomas.frankkila@ericsson.com
- 3768: Was (IETF) (draft-ietf-mmusic-sdp-simulcast); 23/4/20: 0%->90; 9/4/21: RFC 8853 added; / Impacted TSs and TRs: RFC 8853
- 3769: New TR added. 3/3/15: "extensions" added in the title. Mar. 15: 0->10% / Impacted TSs and TRs: 26.922 (new); 26.114 / WI rapporteur name: Muhammed Coban, Qualcomm Incorporated / WI rapporteur e-mail: mcoban@qti.qualcomm.com
- 3770: 3/3/15: created to distinguish TR and TS tasks¦June2015: Compl:10%->40¦Aug2015: 40%->95¦07/09/15: 95%->100 / Impacted TSs and TRs: 26.922 (new); 26.114 / WI rapporteur name: Muhammed Coban, Qualcomm Incorporated / WI rapporteur e-mail: mcoban@qti.qualcomm.com
- 3771: 3/3/15: created to distinguish TR and TS tasks¦June2015: Compl:10%->40¦Aug2015: 40%->95¦07/09/15: 95%->100 / Impacted TSs and TRs: 26.922 (new); 26.114 / WI rapporteur name: Muhammed Coban, Qualcomm Incorporated / WI rapporteur e-mail: mcoban@qti.qualcomm.com
- 3772: 26.114, draft-ietf-payload-flexible-fec-scheme. 7/10/15: rapporteur added; 23/4/20: 10%->100 / Impacted TSs and TRs: 26.114; draft-ietf-payload-flexible-fec-scheme / WI rapporteur name: Muhammed Coban, Qualcomm Incorporated / WI rapporteur e-mail: mcoban@qti.qualcomm.com
- 3773: June2015: Compl:0%->10. Aug: FCD: Jun->Sep15¦07/09/15: 10%->30, FCD:09/15->12/15¦7/12/15: 40%->80, FCD: 12/15->03/16. ES in SP-150642¦7/3/16: 80%->100 / Impacted TSs and TRs: 26.131; 26.132 / WI rapporteur name: Andre Schevciw, Qualcomm Incorporated; Scott Isabelle, Audience Inc. / WI rapporteur e-mail: aschevci@qti.qualcomm.com; sisabelle@audience.com
- 3774: OAM13 is an umbrella Feature for changes that are not part of any other dedicated feature/WI¦June2015: WID:-->SP-150305¦5/10/15: 28.683 added; / Impacted TSs and TRs: 28.683
- 3775: SP#64 work not started. Dec.14: 0->20, cd: 06/15->12/15. Mar 15: 20->30%¦June2015: Compl:30%->50¦07/09/15: 50%->60¦7/12/15: 60%->100 / Impacted TSs and TRs: 28.627; 28.628; 32.103; 32.422; 32.425; 32.442 / WI rapporteur name: Ericsson / WI rapporteur e-mail: robert.petersen@ericsson.com
- 3776: SP#65 updated WID SP-120349=>SP-140538. Completion 12/14=>03/15. Moved to Rel-13. Source of external requirements: NGMN Top OPE Recommendations 1.0 / WI rapporteur name: Huawei / WI rapporteur e-mail: christian.toche@huawei.com
- 3777: SP#65 updated WID SP-120349=>SP-140538. Completion 12/14=>03/15. Moved to Rel-13.. Dec.14: 72->78. Mar 15: 80%¦June2015: Compl:80%->85¦07/09/15: 85%->90¦7/12/15: 90%->100 / Impacted TSs and TRs: New 32.838 / WI rapporteur name: Huawei / WI rapporteur e-mail: christian.toche@huawei.com
- 3778: SP#65 updated WID SP-120349=>SP-140538. Completion 12/14=>03/15. Moved to Rel-13¦7/12/15: 50%->100 / Impacted TSs and TRs: 32.101/2/3.32.111-1.32.111-2.32.111-6.32.15x.32.401.32.411.32.412.32.421.32.422.32.423.32.431.32.432.32.436.32.441.32.442.32.446.32.500.32.501.32.502.32.506.32.521.32.522.32.526.32.531.32.532.32.536.32.551.32.691.32.692.32.696.32.762 / WI rapporteur name: Huawei / WI rapporteur e-mail: christian.toche@huawei.com
- 3779: SP#65 updated WID SP-130641=>SP-140613. Completion 09/14=>12/15. Moved to Rel-13. Completion 09/14=>12/15. Dec.14: 20->30¦June2015: Compl:30%->60¦07/09/15: 60%->80¦7/12/15: 80%->100¦7/12/15: WID:SP-140613->SP-150678 / Impacted TSs and TRs: new TSs 32.863 / WI rapporteur name: Huawei / WI rapporteur e-mail: christian.toche@huawei.com
- 3780: SP#65 moved to Rel-13. Updated WID SP-130042=>SP-140535 (split into Rel-12 Study & Rel-13 normative WI). TR 32.841 was completed as a Rel-12 Study and has triggered this normative work / WI rapporteur name: Intel / WI rapporteur e-mail: joey.chou@intel.com
- 3781: SP#65 updated WID SP-130042=>SP-140535. Completion 09/14=>06/15. Moved to Rel-13. Dec.14: 10->20¦June2015: Compl:20%->70¦07/09/15: 70%->80¦7/12/15: 80%->100 / Impacted TSs and TRs: new (28.680; 28.682); 28.681 / WI rapporteur name: Intel / WI rapporteur e-mail: joey.chou@intel.com
- 3782: SP#65 updated WID SP-130042=>SP-140535. Completion 09/14=>06/15. Moved to Rel-13. 22/01:Acronym modified¦June2015: Compl:5%->20¦07/09/15: 20%->60¦7/12/15: 60%->100 / Impacted TSs and TRs: new 28.403 / WI rapporteur name: Intel / WI rapporteur e-mail: joey.chou@intel.com
- 3783: SP#65 updated WID SP-130263=>SP-140612. Completion 09/14=>06/15. Moved to Rel-13¦June2015: Compl:25%->40¦07/09/15: 40%->50. ES in SP-150708¦7/3/16: 50%->100 / Impacted TSs and TRs: 32.425 / WI rapporteur name: Nokia Networks / WI rapporteur e-mail: Yizhi.yao@nsn.com
- 3784: Mar 15: 0->15%¦June2015: Compl:15%->100 / Impacted TSs and TRs: 32.421; 32.422; 32.423; 32.441; 32.442; 32.446 / WI rapporteur name: Padma Sudarsan (Alcatel-Lucent) / WI rapporteur e-mail: padma.sudarsan<AT>alcatel-lucent<DOT>com
- 3785: CH13 is an umbrella Feature for changes that are not part of any other dedicated feature/WI¦June2015: WID:-->SP-150307
- 3786: Study and specify Gy Reference Point service data flows based online charging for inter-PLMN situations / Impacted TSs and TRs: Stage 2/3 / WI rapporteur name: Alcatel-Lucent / WI rapporteur e-mail: maryse.gardella@alcatel-lucent.com
- 3787: Dec.14: 10->25%. Mar15: 20->60%. 06/15: 100%¦7/12/15: 100%->100 / Impacted TSs and TRs: New 32.843 / WI rapporteur name: Alcatel-Lucent / WI rapporteur e-mail: maryse.gardella@alcatel-lucent.com
- 3788: 07/09/15: 0%->80¦7/12/15: 80%->100 / Impacted TSs and TRs: 32.251; 32.299 / WI rapporteur name: Alcatel-Lucent / WI rapporteur e-mail: maryse.gardella@alcatel-lucent.com
- 3789: Acronym changed to ULRELC-CH. Mar15: 0->5%. CD: 12/14->09/15. 06/15: 20%¦07/09/15: 20%->40¦7/12/15: 40%->100, FCD: 09/15->12/15 / Impacted TSs and TRs: 32.251; 32.260; 32.299; 32.298; / WI rapporteur name: Alcatel-Lucent, Maryse Gardella / WI rapporteur e-mail: Alcatel-Lucent, Maryse <dot> Gardella <at> Alcatel-Lucent <dot> com
- 3790: 06/15: 0->50%¦07/09/15: 50%->100. FCD: 12/15->09/15 / Impacted TSs and TRs: 32.260; 32.299; 32.298 / WI rapporteur name: Gerald Goermer / WI rapporteur e-mail: Gerald <dot> Goermer <at> nsn <dot> com
- 3791: 07/09/15: 0%->30¦7/12/15: 30%->100¦7/12/15: WID:SP-150307->SP-150675 / Impacted TSs and TRs: 32.260; 32.275; 32.299; 32.240; 32.281 / WI rapporteur name: Amdocs, Naceur <dot> Lagha <at> Amdocs <dot> com
- 3792: 07/09/15: 0%->30¦7/12/15: 30%->100 / Impacted TSs and TRs: 32.240; 32.251; 32.299; 32.298 / WI rapporteur name: Alcatel-Lucent, Maryse <dot> Gardella <at> Alcatel-Lucent <dot> com

| ID | WBS | Task | Duration | Start | Finish | Complete | Remaining | Baseline start | Baseline finish | Baseline duration | Total slack | Constraint | Resources | Work | Actual work | Acronym | PCG approved | WI rapporteur name | WI rapporteur e-mail | Release | TSG approved | MCC resp | Acronym_3GU_Export | Status Report |
| --- | --- | --- | --- | --- | --- | --- | --- | --- | --- | --- | --- | --- | --- | --- | --- | --- | --- | --- | --- | --- | --- | --- | --- | --- |
| 3793 | 1464 | **Support of Real-time Transport Protocol (RTP) / Real-time Transport Control Protocol (RTCP) multiplexing (signalling) in IMS** | 595d? | 2013-09-09 A | 2015-12-11 A | 100% |  | 2013-09-09 | 2014-09-12 | 267d? |  |  | C4; C1; C3 | 28464h | 28464h | RTCP_MUX | 31 | Alcatel-Lucent | Albrecht.Schwarz@alcatel-lucent.com | Rel-13 | 61 | Kimmo | RTCP_MUX |  |
| 3794 | 1464.1 | CT4 part of Support of RTP / RTCP multiplexing (signalling) in IMS | 591d? | 2013-09-09 A | 2015-12-11 A | 100% |  | 2013-09-09 | 2014-09-12 | 266d? |  | finish no earlier than 2015-12-11 | C4 | 4728h | 4728h | RTCP_MUX | 31 | Alcatel-Lucent | Albrecht.Schwarz@alcatel-lucent.com | Rel-13 | 61 | Kimmo |  |  |
| 3795 | 1464.2 | CT1 part of Support of RTP / RTCP multiplexing (signalling) in IMS | 591d? | 2013-09-13 A | 2015-12-11 A | 100% |  | 2013-09-10 | 2014-09-12 | 266d? |  | finish no earlier than 2015-12-11 | C1 | 4728h | 4728h | RTCP_MUX | 31 | Alcatel-Lucent | Albrecht.Schwarz@alcatel-lucent.com | Rel-13 | 61 | Frederic |  |  |
| 3796 | 1464.3 | CT3 part of Support of RTP / RTCP multiplexing (signalling) in IMS | 591d? | 2013-09-13 A | 2015-12-11 A | 100% |  | 2013-09-10 | 2014-06-13 | 201d? |  | finish no earlier than 2015-12-11 | C3 | 4728h | 4728h | RTCP_MUX | 31 | Alcatel-Lucent | Albrecht.Schwarz@alcatel-lucent.com | Rel-13 | 61 | Adrian |  |  |
| 3797 | 1465 | **LTE in the 1670-1675 MHz Band for US (on hold till 12/2014)** | 865d? | 2012-03-05 A | 2015-06-09 | 8% | 798.77d? | 2012-03-05 | 2015-06-12 | 865d? | 2805d |  | R4; R2; R3 | 35192h | 2347.6h | LTE_FDD_1670_US | 28 | LightSquared | masoud.olfat@lightsquared.com | Rel-13 | 55 | Issam | LTE_FDD_1670_US |  |
| 3798 | 1465.1 | Core part: LTE in the 1670-1675 MHz Band for US (on hold till 12/2014) | 313d? | 2013-08-06 A | 2015-03-10 | 15% | 266.05d? | 2013-08-06 | 2015-03-13 | 313d? | 2870d | finish no earlier than 2015-03-13 | R4; R2; R3 | 7512h | 1126.8h | LTE_FDD_1670_US-Core | 28 | LightSquared | masoud.olfat@lightsquared.com | Rel-13 | 55 | Issam | LTE_FDD_1670_US-Core | RP-141452 |
| 3799 | 1465.2 | Perf. Part: LTE in the 1670-1675 MHz Band for US (on hold till 12/2014) | 865d? | 2012-03-05 A | 2015-06-09 | 5% | 821.75d? | 2012-03-05 | 2015-06-12 | 865d? | 2805d | finish no earlier than 2015-06-12 | R4 | 6920h | 346h | LTE_FDD_1670_US-Perf | 28 | LightSquared | masoud.olfat@lightsquared.com | Rel-13 | 55 | Issam | LTE_FDD_1670_US-Perf | RP-141452 |
| 3800 | 1466 | **Enhanced Signalling for Inter-eNB Coordinated Multi-Point (CoMP) for LTE** | 328d? | 2014-06-18 A | 2015-09-15 A | 100% |  | 2014-06-13 | 2014-12-05 | 126d? |  |  | R3 | 5248h | 5248h | COMP_LTE_IeNB_sig | 33 | Samsung | sunghwan.won@samsung.com | Rel-13 | 64 |  | COMP_LTE_IeNB_sig |  |
| 3801 | 1466.1 | Core part: Enhanced Signalling for Inter-eNB Coordinated Multi-Point (CoMP) for LTE | 328d? | 2014-06-18 A | 2015-09-15 A | 100% |  | 2014-06-13 | 2014-12-05 | 126d? |  | finish no earlier than 2015-09-15 | R3 | 2624h | 2624h | COMP_LTE_IeNB_sig-Core | 33 | Samsung | sunghwan.won@samsung.com | Rel-13 | 64 |  | COMP_LTE_IeNB_sig-Core | RP-151213 |
| 3802 | 1467 | **2GHz FDD LTE in Region 1 (1980-2010MHz and 2170-2200MHz Bands)** | 592d? | 2014-06-17 A | 2016-09-15 A | 100% |  | 2014-06-13 | 2015-06-12 | 261d? |  |  | R4 | 12096h | 12096h | LTE_1980_2170_REG1 | 33 | DISH Network | johny.kim@dish.com, mariam.sorond@dish.com | Rel-13 | 64 |  | LTE_1980_2170_REG1 |  |
| 3803 | 1467.1 | Core part: 2GHz FDD LTE in Region 1 (1980-2010MHz and 2170-2200MHz Bands) | 393d? | 2014-06-17 A | 2015-12-15 A | 100% |  | 2014-06-13 | 2015-06-12 | 261d? |  | finish no earlier than 2015-12-15 | R4 | 3144h | 3144h | LTE_1980_2170_REG1-Core | 33 | DISH Network | johny.kim@dish.com, mariam.sorond@dish.com | Rel-13 | 64 |  | LTE_1980_2170_REG1-Core | RP-151299 |
| 3804 | 1467.2 | Perf. Part: 2GHz FDD LTE in Region 1 (1980-2010MHz and 2170-2200MHz Bands) | 393d? | 2014-06-18 A | 2015-12-15 A | 100% |  | 2014-06-13 | 2015-06-12 | 261d? |  | finish no earlier than 2015-12-15 | R4 | 3144h | 3144h | LTE_1980_2170_REG1-Perf | 33 | DISH Network | johny.kim@dish.com, mariam.sorond@dish.com | Rel-13 | 64 |  | LTE_1980_2170_REG1-Perf | RP-151299 |
| 3805 | 1467.3 | UE Conformance Test Aspects - FDD LTE band 1980-2010 MHz and 2170-2200MHz (band 65) in Region1 and Region 3 | 134d? | 2016-03-15 A | 2016-09-15 A | 100% |  |  |  |  |  | finish no earlier than 2016-09-15 | R5 | 1072h | 1072h | LTE_1980_2170_REG1_REG3-UEConTest | 36 | Dish Network |  | Rel-13 | 71 |  |  |  |
| 3806 | 1468 | **Self Organizing Networks (SON) for Active Antenna System (AAS) based deployments** | 199d? | 2014-09-12 A | 2015-06-15 A | 100% |  | 2014-06-13 | 2015-06-12 | 261d? |  |  | R3; G2 | 4776h | 4776h | UTRA_LTE_SON_AAS | 33 | Nokia Networks | krzysztof.kordybach@nsn.com | Rel-13 | 65 |  | UTRA_LTE_SON_AAS |  |
| 3807 | 1468.1 | Core part: Self Organizing Networks (SON) for Active Antenna System (AAS) based deployments | 199d? | 2014-09-12 A | 2015-06-15 A | 100% |  | 2014-06-13 | 2015-06-12 | 261d? |  | finish no earlier than 2015-06-15 | R3 | 1592h | 1592h | UTRA_LTE_SON_AAS-Core | 33 | Nokia Networks | krzysztof.kordybach@nsn.com | Rel-13 | 65 |  | UTRA_LTE_SON_AAS-Core | RP-150727 |
| 3808 | 1469 | **Usage Monitoring Control PCC Extension** | 140d? | 2014-12-03 A | 2015-06-16 A | 100% |  |  |  |  |  |  | S2 | 2824h | 2824h | eUMONC | 34 | CTBRI |  | Rel-13 | 66 |  |  |  |
| 3809 | 1469.1 | Stage 2 of Usage Monitoring Control PCC Extension | 140d? | 2014-12-03 A | 2015-06-16 A | 100% |  |  |  |  |  | finish no earlier than 2015-06-16 | S2 | 1120h | 1120h | eUMONC-SA2 | 34 | China Telecom, Jinyan Li | lijy@ctbri.com.cn | Rel-13 | 66 |  |  |  |
| 3810 | 1469.2 | CT3 Aspect of Usage Monitoring Control extension | 73d? | 2014-12-03 A | 2015-03-13 A | 100% |  |  |  |  |  | finish no earlier than 2015-03-13 | C3 | 584h | 584h | eUMONC-CT3 | 34 | ZTE |  | Rel-13 | 66 |  |  |  |
| 3811 | 1470 | **Enhanced P-CSCF discovery using signalling for access to EPC via WLAN** | 115d? | 2014-10-06 A | 2015-03-13 A | 100% |  |  |  |  |  |  | C1 | 2424h | 2424h | ePCSCF_WLAN | 34 | Ericsson |  | Rel-13 | 66 |  |  |  |
| 3812 | 1470.1 | CT1 aspects of Enhanced P-CSCF discovery using signalling for access to EPC via WLAN | 73d? | 2014-12-03 A | 2015-03-13 A | 100% |  |  |  |  |  | finish no earlier than 2015-03-13 | C1 | 584h | 584h | ePCSCF_WLAN | 34 | Ericsson |  | Rel-13 | 66 |  |  |  |
| 3813 | 1470.2 | CT4 aspects of Enhanced P-CSCF discovery using signalling for access to EPC via WLAN | 115d? | 2014-10-06 A | 2015-03-13 A | 100% |  |  |  |  |  | finish no earlier than 2015-03-13 | C4 | 920h | 920h | ePCSCF_WLAN | 34 | Ericsson |  | Rel-13 | 66 |  |  |  |
| 3814 | 1471 | **P-CSCF Restoration Enhancements with WLAN** | 268.05d? | 2014-12-03 A | 2015-12-14 A | 100% |  |  |  |  |  |  | C4 | 6432.4h | 6432.4h | PCSCF_RES_WLAN | 34 | Jean-Jacques Trottin, Alcatel-Lucent | jean-jacques.trottin@alcatel-lucent.com | Rel-13 | 66 |  |  |  |
| 3815 | 1471.1 | CT1 aspects of P-CSCF Restoration Enhancements with WLAN | 268d? | 2014-12-03 A | 2015-12-14 A | 100% |  |  |  |  |  | finish no earlier than 2015-12-11 | C1 | 2144h | 2144h | PCSCF_RES_WLAN | 34 | Jean-Jacques Trottin, Alcatel-Lucent | jean-jacques.trottin@alcatel-lucent.com | Rel-13 | 66 |  |  |  |
| 3816 | 1471.2 | CT4 aspects of P-CSCF Restoration Enhancements with WLAN | 268d? | 2014-12-03 A | 2015-12-11 A | 100% |  |  |  |  |  | finish no earlier than 2015-12-11 | C4 | 2144h | 2144h | PCSCF_RES_WLAN | 34 | Jean-Jacques Trottin, Alcatel-Lucent | jean-jacques.trottin@alcatel-lucent.com | Rel-13 | 66 |  |  |  |

Notes:
- 3793: CP#65 moved to Rel-13. Stage 2/3 / Impacted TSs and TRs: Stage 2/3
- 3794: CP#65 moved to Rel-13. Completion 09/14=>12/15. Dec.14: 10->100 / Impacted TSs and TRs: 23.334; 29.334
- 3795: CP#65 moved to Rel-13. Completion 09/14=>12/15¦7/12/15: 0%->100 / Impacted TSs and TRs: 24.229
- 3796: CP#65 moved to Rel-13. Completion 09/14=>12/15¦8/12/15: 0%->100 / Impacted TSs and TRs: 29.213; 29.214
- 3797: RP#65 FS_LTE_FDD_1670_US is extended to 12/14 and this WI (LTE_FDD_1670_US) is on hold till 12/14 / Impacted TSs and TRs: LTE
- 3798: RP#65 completion 03/15=>06/15. On hold till 12/2014 / Impacted TSs and TRs: 25.101; 25.104; 25.113; 25.133; 25.306; 25.307; 25.331; 25.461; 25.466; 34.124; 36.101; 36.104; 36.113; 36.124; 36.133; 36.307; new 36.832
- 3799: RP#65 completion 06/15=>09/15. . On hold till 12/2014 / Impacted TSs and TRs: 25.133; 25.306; 25.307; 25.331; 25.461; 25.466; 34.124; 36.113; 36.124; 36.133; 36.141; 36.307
- 3800: Triggered by TR 36.874 Study on Coordinated Multi-Point (CoMP) operation for LTE with Non-Ideal Backhaul (UID_600015) / Impacted TSs and TRs: LTE
- 3801: CD:Thu 11/12/14->Mon 15/06/15¦Compl:0%->15%¦Stat Rep: -->RP-141805 1st Apr 15: Compl:15%->30% 1st Apr 15: Stat Rep: RP-141805->RP-150162 03/07/15: Compl:30%->90% 03/07/15: CD:Mon 15/06/15->Tue 15/09/15 03/07/15: Stat Rep: RP-150162->RP-150846 29/09/1 / Impacted TSs and TRs: 36.300; 36.423
- 3802: Triggered by TR 37.846 Study on 2GHz FDD for UTRA and LTE in Region 1 (1980-2010MHz and 2170-2200MHz Bands) FS_UTRA_LTE_1980_2170_REG1 / Impacted TSs and TRs: LTE
- 3803: CD:Fri 12/06/15->Mon 15/06/15¦Compl:5%->15%¦Stat Rep: RP-141627->RP-141795 1st Apr 15: Compl:15%->35% 1st Apr 15: WID: RP-141710->RP-150424 1st Apr 15: Stat Rep: RP-141795->RP-150106 03/07/15: Compl:35%->70% 03/07/15: CD:Mon 15/06/15->Tue 15/12/15 03 / Impacted TSs and TRs: 36.101; 36.104; 36.133; 36.141; 36.307; generic 36.853 (3 Band CA with 1UL); New 36.862 (Technical Report for 2 GHz Band in Region 1)
- 3804: CD:Fri 12/06/15->Mon 15/06/15¦Compl:0%->0%¦Stat Rep: RP-141627->RP-141795 1st Apr 15: WID: RP-141710->RP-150424 1st Apr 15: Stat Rep: RP-141795->RP-150106 03/07/15: CD:Mon 15/06/15->Tue 15/12/15 03/07/15: Stat Rep: RP-150106->RP-150705 29/09/15: Stat / Impacted TSs and TRs: 36.101; 36.104; 36.133; 36.141; 36.307; 36.862
- 3805: testing REL-13 LTE_1980_2170_REG1-Core and LTE_1980_2170_REG3-Core¦
- 3806: Triggered by TR 37.822 Study on Next-Generation SON for UTRA and LTE (FS_UTRA_LTE_NG_SON) / Impacted TSs and TRs: LTE
- 3807: CD:Tue 16/06/15->Mon 15/06/15¦Compl:0%->15%¦Stat Rep: -->RP-141854 1st Apr 15: Compl:15%->25% 1st Apr 15: Stat Rep: RP-141854->RP-150110 03/07/15: Compl:25%->100% 03/07/15: Stat Rep: RP-150110->RP-150727 / Impacted TSs and TRs: 36.300; 36.423; 36.413; 25.413
- 3809: June2015: Compl:6%->100. Verbal indication from SA2 chair / Impacted TSs and TRs: 23.203
- 3810: Mar.15: 10->100% / Impacted TSs and TRs: 29.212; 29.215
- 3812: . 12/12:0->100%. 5/5/15: acronym changed from ePCSCF_WLAN-CT1 to ePCSCF_WLAN / Impacted TSs and TRs: 24.229; 24.302
- 3813: Mar.15: 0->100%. 5/5/15: acronym changed from ePCSCF_WLAN-CT1 to ePCSCF_WLAN / Impacted TSs and TRs: 29.274; 29.275
- 3814: WID added, acronym. June 2015: WID: CP-140995-> CP-150275
- 3815: CT4->CT1. 2/4/15: acronym changed to PCSCF_RES_WLAN¦June2015: Compl:0%->10. June 2015: WID: CP-140995-> CP-150275¦07/09/15: 10%->70¦7/12/15: 70%->100 / Impacted TSs and TRs: 24.302; 24.229; 24.244; 24.008
- 3816: Dec.14: 0->5%. Mar.15: 5->100%. 2/4/15: acronym changed to PCSCF_RES_WLAN¦June2015: Compl:100%->75. June 2015: WID: CP-140995-> CP-150275¦07/09/15: 75%->85¦7/12/15: 85%->100 / Impacted TSs and TRs: New 29.8xy; 23.380; 29.273; 29.274; 29.275; 23.008

| ID | WBS | Task | Duration | Start | Finish | Complete | Remaining | Total slack | Constraint | Resources | Work | Actual work | Acronym | PCG approved | WI rapporteur name | WI rapporteur e-mail | Release | TSG approved |
| --- | --- | --- | --- | --- | --- | --- | --- | --- | --- | --- | --- | --- | --- | --- | --- | --- | --- | --- |
| 3817 | 1472 | **Mobile Equipment Identity signalling over WLAN** | 69d? | 2015-06-15 A | 2015-09-17 A | 100% |  |  |  | C4 | 1656h | 1656h | MEI_WLAN | 35 | Bruno Landais, Alcatel-Lucent | bruno.landais@alcatel-lucent.com | Rel-13 | 68 |
| 3818 | 1472.1 | CT1 aspects of Mobile Equipment Identity signalling over WLAN | 69d? | 2015-06-15 A | 2015-09-17 A | 100% |  |  | start no earlier than 2015-06-15 | C1 | 552h | 552h | MEI_WLAN | 35 | Bruno Landais, Alcatel-Lucent | bruno.landais@alcatel-lucent.com | Rel-13 | 68 |
| 3819 | 1472.2 | CT4 aspects of Mobile Equipment Identity signalling over WLAN | 69d? | 2015-06-15 A | 2015-09-17 A | 100% |  |  | start no earlier than 2015-06-15 | C4 | 552h | 552h | MEI_WLAN | 35 | Bruno Landais, Alcatel-Lucent | bruno.landais@alcatel-lucent.com | Rel-13 | 68 |
| 3820 | 1473 | Authentication Signalling Improvements for WLAN | 195d? | 2015-06-15 A | 2016-03-11 A | 100% |  |  | finish no earlier than 2016-03-11 | C1 | 1560h | 1560h | ASI_WLAN | 35 | Youyang Yu | yuyouyang@huawei.com | Rel-13 | 68 |
| 3821 | 1474 | **Stage-3 SAE Protocol Development - Phase 4** | 268d? | 2014-12-03 A | 2015-12-11 A | 100% |  |  |  | C1 | 8576h | 8576h | SAES4 | 34 | interdigital |  | Rel-13 | 66 |
| 3822 | 1474.1 | SAE Protocol Development (Stage 3) - Phase 4 | 268d? | 2014-12-03 A | 2015-12-11 A | 100% |  |  | start no earlier than 2014-12-03 | C1 | 2144h | 2144h | SAES4 | 34 | interdigital |  | Rel-13 | 66 |
| 3823 | 1474.2 | CS Fallback in EPS - Phase 4 | 268d? | 2014-12-03 A | 2015-12-11 A | 100% |  |  | start no earlier than 2014-12-03 | C1 | 2144h | 2144h | SAES4-CSFB | 34 | interdigital |  | Rel-13 | 66 |
| 3824 | 1474.3 | SAE for support for non-3GPP accesses - Phase 4 | 268d? | 2014-12-03 A | 2015-12-11 A | 100% |  |  | start no earlier than 2014-12-03 | C1 | 2144h | 2144h | SAES4-non3GPP | 34 | interdigital |  | Rel-13 | 66 |
| 3825 | 1475 | **Interworking solution for Called IN number and original called IN number ISUP parameters** | 73d? | 2014-12-03 A | 2015-03-13 A | 100% |  |  |  | C1; C3 | 2354.5h | 2354.5h | INNB_IW | 34 | Orange |  | Rel-13 | 66 |
| 3826 | 1475.1 | Interworking solution for Called IN number and original called IN number ISUP parameters | 73d? | 2014-12-03 A | 2015-03-13 A | 100% |  |  | start no earlier than 2014-12-03 | C1 | 584h | 584h | INNB_IW | 34 | Orange |  | Rel-13 | 66 |
| 3827 | 1475.2 | (IETF) CT1 part of Interworking solution for Called IN number and original called IN number ISUP parameters | 51.75d? | 2014-12-03 A | 2015-03-10 A | 100% |  |  | finish no earlier than 2015-03-10 | C1-IETF | 414h | 414h | INNB_IW | 34 | Orange |  | Rel-13 | 66 |
| 3828 | 1475.3 | CT3 aspects of Interworking solution for Called IN number and original called IN number ISUP parameters | 73d? | 2014-12-03 A | 2015-03-13 A | 100% |  |  | finish no earlier than 2015-03-13 | C3 | 584h | 584h | INNB_IW | 34 | Orange |  | Rel-13 | 66 |
| 3829 | 1476 | **Warning Status Report in EPS** | 204d? | 2014-12-03 A | 2015-09-14 A | 100% |  |  |  | C4 | 4896h | 4896h | WSR_EPS | 34 | one2many |  | Rel-13 | 66 |
| 3830 | 1476.1 | CT1 aspects of Warning Status Report in EPS | 204d? | 2014-12-03 A | 2015-09-14 A | 100% |  |  | start no earlier than 2014-12-03 | C1 | 1632h | 1632h | WSR_EPS | 34 | one2many |  | Rel-13 | 66 |
| 3831 | 1476.2 | CT4 aspects of Warning Status Report in EPS | 204d? | 2014-12-03 A | 2015-09-14 A | 100% |  |  | finish no earlier than 2015-09-14 | C4 | 1632h | 1632h | WSR_EPS | 34 | one2many |  | Rel-13 | 66 |
| 3832 | 1477 | Shared Data Update for Multiple Subscriber | 1d? | 2014-12-03 A | 2014-12-03 A | 100% |  |  | start no earlier than 2014-12-03 | C4 | 8h | 8h | SHARED_SubData_UPD | 34 | Huawei, Susan Shi | susan.shishufeng@huawei.com | Rel-13 | 66 |
| 3833 | 1478 | **IMS Stage-3 IETF Protocol Alignment** | 666d? | 2014-12-03 A | 2017-06-20 | 70% | 199.79d? | 2274d |  | C1 | 11760h | 6003.22h | IMSProtoc7 | 34 | Alcatel-Lucent | Keith Drage | Rel-13 | 66 |
| 3834 | 1478.1 | CT1 aspects of IMS Stage-3 IETF Protocol Alignment | 268d? | 2014-12-03 A | 2015-12-11 A | 100% |  |  | finish no earlier than 2015-12-11 | C1 | 2144h | 2144h | IMSProtoc7 | 34 | Alcatel-Lucent | Keith Drage | Rel-13 | 66 |
| 3835 | 1478.2 | (IETF) CT1 aspects of IMS Stage-3 IETF Protocol Alignment | 268d? | 2016-06-13 A | 2017-06-20 | 10% | 241.2d? | 2274d | finish no earlier than 2015-12-11 | C1 | 2144h | 214.4h | IMSProtoc7 | 34 | Alcatel-Lucent | Keith Drage | Rel-13 | 66 |
| 3836 | 1478.3 | CT3 aspects of IMS Stage-3 IETF Protocol Alignment | 268d? | 2014-12-03 A | 2015-12-11 A | 100% |  |  | start no earlier than 2014-12-03 | C3 | 2144h | 2144h | IMSProtoc7 | 34 | Alcatel-Lucent | Keith Drage | Rel-13 | 67 |
| 3837 | 1479 | Retry restriction for Improving System Efficiency | 205d? | 2015-03-04 A | 2015-12-15 A | 100% |  |  | finish no earlier than 2015-12-15 | C1 | 1640h | 1640h | RISE | 34 | Huawei, Lin Shu | shulin@huawei.com | Rel-13 | 67 |
| 3838 | 1480 | **H.248 Aspects of WebRTC Data Channel on IMS Access Gateway** | 268d? | 2015-03-04 A | 2016-03-11 A | 100% |  |  |  | C4 | 4288h | 4288h | WebRTCH248DC | 34 | China Mobile, Xiaoning Du | duxiaoning@chinamobile.com | Rel-13 | 67 |
| 3839 | 1480.1 | CT4 Aspect of H.248 Aspects of WebRTC Data Channel on IMS Access Gateway | 268d? | 2015-03-04 A | 2016-03-11 A | 100% |  |  | finish no earlier than 2016-03-11 | C4 | 2144h | 2144h | WebRTCH248DC | 34 | China Mobile, Xiaoning Du. ES in 639 | duxiaoning@chinamobile.com | Rel-13 | 67 |
| 3840 | 1481 | Continuation of the Overload Control for PCC based Diameter applications | 203d? | 2015-03-04 A | 2015-12-11 A | 100% |  |  | finish no earlier than 2015-12-11 | C3 | 1624h | 1624h | cDOCME_PCC | 34 | ZTE, Zhou Xiaoyun | zhou.xiaoyun@zte.com.cn | Rel-13 | 67 |
| 3841 | 1482 | Review of dedicated 3GPP UICC features | 200d? | 2015-03-09 A | 2015-12-11 A | 100% |  |  | finish no earlier than 2015-12-11 | C6 | 1600h | 1600h | Red_UCe | 34 | Blackberry, Adrian Buckley | abuckley@blackberry.com | Rel-13 | 67 |

Notes:
- 3817: Impacted TSs and TRs: 24.244; 24.302; 29.273; 29.274; 29.275; 23.008
- 3818: 07/09/15: 0%->80¦7/12/15: 80%->100 / Impacted TSs and TRs: 24.244; 24.302
- 3819: 07/09/15: 0%->90¦7/12/15: 90%->100 / Impacted TSs and TRs: 29.273; 29.274; 29.275; 23.008
- 3820: 07/09/15: 0%->40¦7/12/15: 40%->95. FCD -> 03/16, ES in CP-150727¦7/3/16: 95%->100 / Impacted TSs and TRs: 24.302; 24.244
- 3821: WP Structure created 24/03/15 to avoid confusion in Acronyms / Impacted TSs and TRs: 23.12; 24.008; 24.167; 24.229; 24.301; 24.302; 24.303; 24.304; 24.305; 24.312; 29.018; 29.118
- 3822: WP Structure created 24/03/15 to avoid confusion in Acronyms. 5/5/15: acronym changed from "SAES4-CT1"¦June2015: Compl:0%->30¦07/09/15: 30%->70¦7/12/15: 70%->100
- 3823: WP Structure created 24/03/15 to avoid confusion in Acronyms¦June2015: Compl:0%->30¦07/09/15: 30%->70¦7/12/15: 70%->100
- 3824: WP Structure created 24/03/15 to avoid confusion in Acronyms¦June2015: Compl:0%->30¦07/09/15: 30%->50¦7/12/15: 50%->100
- 3826: 5/5/15: created¦June2015: Compl:0%->70¦07/09/15: 70%->100 / Impacted TSs and TRs: 24.229
- 3827: Mar15: resp WG:C1->C1-IETF. WID changed from INNB_IW-CT1 / Impacted TSs and TRs: draft-mohali-dispatch-cause-for-service-number
- 3828: Mar.15: 80->90%. WID changed from INNB_IW-CT3¦June2015: Compl:0%->98¦07/09/15: 98%->99¦7/12/15: 99%->100
- 3829: 5/5/15: acronym changed from "WSR_EP"¦7/12/15: WID:CP-140998->CP-150792
- 3830: 2/4/15: acronym changed to WSR_EP. 5/5/15: acronym changed from "WSR_EP"¦07/09/15: 0%->25¦7/12/15: 25%->100¦7/12/15: WID:CP-140998->CP-150792 / Impacted TSs and TRs: New 23.712
- 3831: 2/4/15: acronym changed to WSR_EP. 5/5/15: acronym changed from "WSR_EP"¦7/12/15: 0%->100¦7/12/15: WID:CP-140998->CP-150792
- 3832: Mar.15: 0->50%, WID: CP-140804->CP-150013¦June2015: Compl:50%->95¦07/09/15: 95%->100 / Impacted TSs and TRs: 29.328; 29.364
- 3833: Mar.15: 0->10% / Impacted TSs and TRs: 23.218; 24.998; 24.930
- 3834: Mar.15: 0->10%¦June2015: Compl:10%->30¦07/09/15: 30%->70¦7/12/15: 70%->100
- 3835: Impacted TSs and TRs: draft-ietf-mmusic-dtls-sdp; draft-ietf-mmusic-4572-update
- 3836: 2/4/15: added, following CT3 chair's info that the WID also has a CT3 part¦June2015: Compl:0%->20¦07/09/15: 20%->40¦7/12/15: 40%->100
- 3837: Continuation of Rel-12 SINE UID 620006. 5/5/15: acronym changed from "RISE"¦June2015: Compl:0%->10¦07/09/15: 10%->70¦14/09/15: WID:CP-150092->CP-150495¦7/12/15: 70%->100
- 3838: Impacted TSs and TRs: 23.334
- 3839: June2015: Compl:0%->10¦07/09/15: 10%->20¦7/12/15: 20%->90¦7/3/16: 90%->100 / Impacted TSs and TRs: 23.334
- 3840: Relates to UID 580026 (Study on Diameter overload control mechanism)¦June2015: Compl:0%->100 / Impacted TSs and TRs: 29.212; 29.215; 29.219; 29.217
- 3841: Results from the homonymous Study¦June2015: Compl:0%->60¦07/09/15: 60%->75¦7/3/16: 75%->100 / Impacted TSs and TRs: 31.102; 31.111; 31.121; 31.124

| ID | WBS | Task | Type | Duration | Start | Finish | Complete | Baseline start | Baseline finish | Baseline duration | Constraint | Resources | Work | Actual work | Acronym | PCG approved | WI rapporteur name | WI rapporteur e-mail | Release | TSG approved | Status Report | Acronym_3GU_Export | TSG stopped | MCC resp |
| --- | --- | --- | --- | --- | --- | --- | --- | --- | --- | --- | --- | --- | --- | --- | --- | --- | --- | --- | --- | --- | --- | --- | --- | --- |
| 3842 | 1483 | **Controlling IMS Media Plane with SDP Capability** |  | 195d? | 2015-06-15 A | 2016-03-11 A | 100% |  |  |  |  | C4 | 4680h | 4680h | SDPCN_IMS | 35 | Weiwei(Tommy) Yang, Huawei. ES in 640 | tommy@huawei.com | Rel-13 | 68 |  |  |  |  |
| 3843 | 1483.1 | CT3 aspects of Controlling IMS Media Plane with SDP Capability |  | 195d? | 2015-06-15 A | 2016-03-11 A | 100% |  |  |  | finish no earlier than 2016-03-11 | C3 | 1560h | 1560h | SDPCN_IMS | 35 | Weiwei(Tommy) Yang, Huawei. ES in 640 | tommy@huawei.com | Rel-13 | 68 |  |  |  |  |
| 3844 | 1483.2 | CT4 aspects of Controlling IMS Media Plane with SDP Capability |  | 195d? | 2015-06-15 A | 2016-03-11 A | 100% |  |  |  | finish no earlier than 2016-03-11 | C4 | 1560h | 1560h | SDPCN_IMS | 35 | Weiwei(Tommy) Yang, Huawei. ES in 640 | tommy@huawei.com | Rel-13 | 68 |  |  |  |  |
| 3845 | 1484 | **(SA66: on hold) Co-ordinated packet data network gateway (P-GW) change for SIPTO** |  | 66d? | 2014-06-18 A | 2014-09-16 A | 100% | 2014-06-18 | 2014-09-17 | 66d? |  | S1 | 1056h | 1056h | CSIPTO | 33 | Intel | Eric.siow@intel.com | Rel-13 | 64 | S1-143306 | CSIPTO |  |  |
| 3846 | 1484.1 | Stage 1 for Co-ordinated packet data network gateway (P-GW) change for SIPTO |  | 66d? | 2014-06-18 A | 2014-09-16 A | 100% | 2014-06-18 | 2014-09-17 | 66d? | finish no earlier than 2014-09-17 | S1 | 528h | 528h | CSIPTO-ST1 | 33 | Intel | Eric.siow@intel.com | Rel-13 | 64 | S1-143306 | CSIPTO |  |  |
| 3847 | 1485 | **Enhanced CS Fallback (CSFB)** |  | 196d? | 2014-06-18 A | 2015-03-13 A | 100% | 2014-06-18 | 2015-03-18 | 196d? |  | S2; S3 | 2600h | 2600h | eCSFB | 33 | China Unicom | Yang Xu (xuyang49@chinaunicom.cn) | Rel-13 | 64 |  | eCSFB |  |  |
| 3848 | 1485.1 | TR for Enhanced CS Fallback (CSFB) |  | 128d? | 2014-06-18 A | 2014-12-12 A | 100% | 2014-06-18 | 2014-12-10 | 126d? | finish no earlier than 2014-12-12 | S2 | 1024h | 1024h | eCSFB | 33 | China Unicom | Yang Xu (xuyang49@chinaunicom.cn) | Rel-13 | 64 |  |  |  |  |
| 3849 | 1485.2 | Deleted - Stage 2 for Enhanced CS Fallback (CSFB) | milestone | 0d? | 2015-03-13 A | 2015-03-13 A | 100% | 2014-06-18 | 2015-03-18 | 196d? | start no earlier than 2015-03-13 | S2 |  |  | eCSFB | 33 | China Unicom | Yang Xu (xuyang49@chinaunicom.cn) | Rel-13 | 64 |  |  | SP-69 |  |
| 3850 | 1485.3 | Deleted - Security for Enhanced CS Fallback (CSFB) |  | 1d? | 2014-09-18 A | 2014-09-18 A | 100% |  |  |  | start no earlier than 2014-09-17 | S3 | 8h | 8h | eCSFB | 33 | China Unicom | Feng Gao (gaofeng149@chinaunicom.cn) | Rel-13 | 65 |  |  | SP-69 |  |
| 3851 | 1486 | **SRVCC Enhancements for Transcoding Avoidance** |  | 196d? | 2014-09-19 A | 2015-06-17 A | 100% |  |  |  |  | S2 | 2592h | 2592h | SETA | 33 | Ericsson | George.Foti@ericsson.com | Rel-13 | 65 |  | SETA |  |  |
| 3852 | 1486.1 | TR for SRVCC Enhancements for Transcoding Avoidance |  | 128d? | 2014-09-19 A | 2015-03-13 A | 100% |  |  |  | finish no earlier than 2015-03-13 | S2 | 1024h | 1024h | SETA-SA2TR | 33 | Ericsson | George.Foti@ericsson.com | Rel-13 | 65 |  |  |  |  |
| 3853 | 1486.2 | Deleted - Stage 2 for SRVCC Enhancements for Transcoding Avoidance | milestone | 0d? | 2015-06-17 A | 2015-06-17 A | 100% |  |  |  | start no earlier than 2015-06-17 | S2 |  |  | SETA-SA2 | 33 | Ericsson | George.Foti@ericsson.com | Rel-13 | 65 |  |  | SP-69 |  |
| 3854 | 1487 | **Base Station (BS) RF requirements for Active Antenna System (AAS)** |  | 933d? | 2013-03-04 A | 2016-09-15 A | 100% | 2013-03-04 | 2014-12-05 | 465d? |  | R4 | 21184h | 21184h | AAS_BS_LTE_UTRA | 30 | Huawei | ronnie.zhang@huawei.com | Rel-13 | 59 |  | AAS_BS_LTE_UTRA |  | Issam |
| 3855 | 1487.1 | Core part: Base Station (BS) RF requirements for Active Antenna System (AAS) |  | 793d? | 2013-03-04 A | 2016-03-15 A | 100% | 2013-03-04 | 2014-09-12 | 401d? | finish no earlier than 2016-03-15 | R4 | 6344h | 6344h | AAS_BS_LTE_UTRA-Core | 30 | Huawei | ronnie.zhang@huawei.com | Rel-13 | 59 | RP-151241 | AAS_BS_LTE_UTRA-Core |  | Issam |
| 3856 | 1487.2 | Perf. part: Base Station (BS) RF requirements for Active Antenna System (AAS) |  | 922d? | 2013-03-15 A | 2016-09-15 A | 100% | 2013-03-07 | 2014-12-05 | 461d? | finish no earlier than 2016-09-15 | R4 | 7376h | 7376h | AAS_BS_LTE_UTRA-Perf | 30 | Huawei | ronnie.zhang@huawei.com | Rel-13 | 59 | RP-151241 | AAS_BS_LTE_UTRA-Perf |  | Issam |
| 3857 | 1488 | **Enhanced LTE Device to Device Proximity Services** |  | 460d? | 2014-12-15 A | 2016-09-15 A | 100% |  |  |  |  | R2 | 11016h | 11016h | LTE_eD2D_Prox | 34 | Qualcomm | Qualcomm | Rel-13 | 66 |  |  |  |  |
| 3858 | 1488.1 | Core part: Enhanced LTE Device to Device Proximity Services |  | 152.33d? | 2015-08-14 A | 2016-03-15 A | 100% |  |  |  | finish no earlier than 2016-03-15 | R2; R1; R3 | 3656h | 3656h | LTE_eD2D_Prox-Core | 34 | Qualcomm Incorporated, Shailesh Patil | patil@qti.qualcomm.com | Rel-13 | 66 | RP-151337 |  |  |  |
| 3859 | 1488.2 | Perf. part: Enhanced LTE Device to Device Proximity Services |  | 460d? | 2014-12-15 A | 2016-09-15 A | 100% |  |  |  | finish no earlier than 2016-09-15 | R4 | 3680h | 3680h | LTE_eD2D_Prox-Perf | 34 | Qualcomm | Qualcomm | Rel-13 | 66 | RP-151337 |  |  |  |
| 3860 | 1489 | **Radiated requirements for the verification of multi-antenna reception performance of UEs** |  | 327d? | 2014-12-15 A | 2016-03-15 A | 100% |  |  |  |  | R4 | 5232h | 5232h | UTRA_LTE_MIMO_OTA | 34 | Intel | Intel | Rel-13 | 66 | RP-171826 |  |  |  |
| 3861 | 1489.1 | Core part: Radiated requirements for the verification of multi-antenna reception performance of UEs |  | 327d? | 2014-12-15 A | 2016-03-15 A | 100% |  |  |  | finish no earlier than 2016-03-15 | R4 | 2616h | 2616h | UTRA_LTE_MIMO_OTA-Core | 34 | Intel | Intel | Rel-13 | 66 | RP-151573 |  |  |  |
| 3862 | 1490 | **UE core requirements for uplink 64 QAM** |  | 197d? | 2014-12-15 A | 2015-09-15 A | 100% |  |  |  |  | R4 | 3152h | 3152h | LTE_UL64QAM | 34 | Huawei | Huawei | Rel-13 | 66 |  |  |  |  |
| 3863 | 1490.1 | Core part: UE core requirements for uplink 64 QAM |  | 197d? | 2014-12-15 A | 2015-09-15 A | 100% |  |  |  | finish no earlier than 2015-09-15 | R4 | 1576h | 1576h | LTE_UL64QAM-Core | 34 | Huawei | Huawei | Rel-13 | 66 | RP-151244 |  |  |  |
| 3864 | 1491 | UE Conformance Test Aspects - Core Requirements for Uplink 64QAM for E-UTRA |  | 132d? | 2015-06-15 A | 2015-12-15 A | 100% |  |  |  | finish no earlier than 2015-12-15 | R5 | 1056h | 1056h | LTE_UL64QAM-UEConTest | 35 | CMCC |  | Rel-13 | 68 | RP-151174 |  |  |  |
| 3865 | 1492 | **Performance requirements of MMSE-IRC receiver for LTE BS** |  | 393d? | 2014-12-15 A | 2016-06-15 A | 100% |  |  |  |  | R4 | 6288h | 6288h | LTE_MMSE_IRC_BS | 34 | China Telecom | China Telecom | Rel-13 | 66 |  |  |  |  |
| 3866 | 1492.1 | Perf. part: Performance requirements of MMSE-IRC receiver for LTE BS |  | 393d? | 2014-12-15 A | 2016-06-15 A | 100% |  |  |  | finish no earlier than 2016-06-15 | R4 | 3144h | 3144h | LTE_MMSE_IRC_BS-Perf | 34 | China Telecom | China Telecom | Rel-13 | 66 | RP-151215 |  |  |  |

Notes:
- 3842: Impacted TSs and TRs: 23.334; 29.334; 29.162; 29.238; 23.333; 29.333; 29.163; 29.332; 29.292; 29.232; 29.235
- 3843: 7/12/15: 0%->90. FCD->03/16. ES in CP-150614¦7/3/16: 90%->100 / Impacted TSs and TRs: 29.162; 29.163; 29.292; 29.235
- 3844: 07/09/15: 0%->5¦7/12/15: 5%->70. FCD->03/16. ES in CP-150614¦7/3/16: 70%->100 / Impacted TSs and TRs: 23.334; 29.334; 29.238; 23.333; 29.333; 29.332; 29.232
- 3845: SP#65 completed. Updated WID SP-140235=>SP-140509. Triggered by Rel-13 Study TR 22.828 (FS_CSIPTO) / Impacted TSs and TRs: 22.101
- 3846: SP#65 completed. Updated WID SP-140235=>SP-140509. Triggered by Rel-13 Study TR 22.828 (FS_CSIPTO). Dec.14: former S1-only feature split / Impacted TSs and TRs: 22.101
- 3847: SP#65 updated ID SP-140285=>SP-140579 (added SA3 part). Linked to Rel-8 WIs Single Radio Voice Call Continuity for 3GPP (SAES-SRVCC) and CS Fallback in EPS (SAES-CSFB) / Impacted TSs and TRs: Stage 2
- 3848: SP#65 updated ID SP-140285=>SP-140579 (added SA3 part). Dec.14: 35->85%¦14/09/15: 85%->100. SA#69: decision not to continue the work on this. No normative work. / Impacted TSs and TRs: New 23.772
- 3849: SP#65 updated ID SP-140285=>SP-140579 (added SA3 part) / Impacted TSs and TRs: 23.272
- 3850: SP#65 updated ID SP-140285=>SP-140579¦14/09/15: 0%->100. SA#69: deleted, since SA2 has stopped the work.
- 3851: Enhance chances for end-to-end transcoder free operation (TrFo) where possible/ ensure proper CS radio resources are reserved for optimal RAN codec. Address TrFo of EVS codecs during SRVCC that are not covered by Rel-12 / Impacted TSs and TRs: Stage 2
- 3852: Dec.14: 0->70%¦14/09/15: 70%->100. Stopped without conclusion, no intention to continue the study nor to do any mormative work. / Impacted TSs and TRs: New 23.7xy
- 3853: SA#69: stop the work on this. / Impacted TSs and TRs: 23.216; 23.237
- 3854: Triggered by Rel-12 TR 37.840 Study of RF and EMC Requirements for Active Antenna Array System BS (FS_AAS_BS_LTE_UTRA) / Impacted TSs and TRs: UTRA; LTE; GERAN
- 3855: ¦CD:Thu 11/12/14->Tue 15/12/15¦WID: RP-141966->RP-142235¦Stat Rep: RP-141249->RP-141908¦Release: Rel-12->Rel-13 03/07/15: Stat Rep: RP-141908->RP-150687 29/09/15: Compl:75%->80% 29/09/15: Stat Rep: RP-150687->RP-151241¦ / Impacted TSs and TRs: New 37.142 (AAS BS Tx & Rx); New 37.842; 37.114; 37.145-1; 37.145-2
- 3856: ¦CD:Sat 18/06/16->Wed 15/06/16¦WID: RP-141966->RP-142235¦Stat Rep: RP-141249->RP-141908¦Release: Rel-12->Rel-13 03/07/15: Stat Rep: RP-141908->RP-150687 29/09/15: Stat Rep: RP-150687->RP-151241 22/3/16: Compl:2 26/9/16: Compl:95%->100% / Impacted TSs and TRs: New 37.1xy (AAS BS conformance testing)
- 3858: Rapporteur details and involved WGs updated 1st Apr 15: WID: RP-142311->RP-150441 1st Apr 15: Stat Rep: ->RP-150095 03/07/15: Compl:0%->32% 03/07/15: Stat Rep: RP-150095->RP-150795 29/09/15: Compl:32%->55% 29/09/15: Stat Rep: RP-150795->RP-151337¦
- 3859: 1st Apr 15: WID: RP-142311->RP-150441 1st Apr 15: Stat Rep: ->RP-150095 03/07/15: Stat Rep: RP-150095->RP-150795 29/09/15: Stat Rep: RP-150795->RP-151337¦1/1/16: CD¦22/3/16: Compl:0%->10%;26/9/16: Compl:85%->100%
- 3861: 1st Apr 15: Compl:0%->5% 1st Apr 15: WID: RP-142221->RP-150261 1st Apr 15: Stat Rep: ->RP-150260 03/07/15: Compl:5%->15% 03/07/15: Stat Rep: RP-150260->RP-150746 29/09/15: Compl:15%->25% 29/09/15: WID: RP-150261->RP-151574 29/09/15: Stat Rep: RP-15074
- 3863: 1st Apr 15: Compl:0%->10% 1st Apr 15: Stat Rep: ->RP-150232 03/07/15: Compl:10%->90% 03/07/15: WID: RP-142222->RP-150691 03/07/15: Stat Rep: RP-150232->RP-150688 29/09/15: Compl:90%->100% 29/09/15: Stat Rep: RP-150688->RP-151244
- 3864: tested Core part: LTE_UL64QAM-Core which is not yet completed 29/09/15: Compl:0%->5% 29/09/15: Stat Rep: -->RP-151174 1/1/16: Compl:5%->100%
- 3866: 1st Apr 15: Compl:0%->10% 1st Apr 15: WID: RP-142223->RP-150206 1st Apr 15: Stat Rep: ->RP-150204 03/07/15: Compl:10%->35% 03/07/15: Stat Rep: RP-150204->RP-150630 29/09/15: Compl:35%->50% 29/09/15: Stat Rep: RP-150630->RP-151215¦

| ID | WBS | Task | Duration | Start | Finish | Complete | Constraint | Resources | Work | Actual work | Acronym | PCG approved | WI rapporteur name | WI rapporteur e-mail | Release | TSG approved | Status Report |
| --- | --- | --- | --- | --- | --- | --- | --- | --- | --- | --- | --- | --- | --- | --- | --- | --- | --- |
| 3867 | 1493 | **CRS Interference Mitigation for LTE Homogenous Deployments** | 327d? | 2014-12-15 A | 2016-03-15 A | 100% |  | R4 | 5232h | 5232h | LTE_CRSIM | 34 | Ericsson | Ericsson | Rel-13 | 66 |  |
| 3868 | 1493.1 | Perf. part: CRS Interference Mitigation for LTE Homogenous Deployments | 327d? | 2014-12-15 A | 2016-03-15 A | 100% | finish no earlier than 2016-03-15 | R4 | 2616h | 2616h | LTE_CRSIM-Perf | 34 | Ericsson | Ericsson | Rel-13 | 66 | RP-151171 |
| 3869 | 1494 | **Dual Connectivity enhancements for LTE** | 328d? | 2015-03-16 A | 2016-06-15 A | 100% |  | R2 | 6824h | 6824h | LTE_dualC_enh | 34 | NTT DOCOMO |  | Rel-13 | 67 |  |
| 3870 | 1494.1 | Core part: Dual Connectivity enhancements for LTE | 197d? | 2015-03-16 A | 2015-12-15 A | 100% | finish no earlier than 2015-12-15 | R2 | 1576h | 1576h | LTE_dualC_enh-Core | 34 | NTT DOCOMO |  | Rel-13 | 67 | RP-151330 |
| 3871 | 1494.2 | Perf. part: Dual Connectivity enhancements for LTE | 328d? | 2015-03-16 A | 2016-06-15 A | 100% | finish no earlier than 2016-06-15 | R4 | 2624h | 2624h | LTE_dualC_enh-Perf | 34 | NTT DOCOMO |  | Rel-13 | 67 | RP-151330 |
| 3872 | 1495 | **Multicarrier Load Distribution of UEs in LTE** | 395d? | 2015-03-16 A | 2016-09-15 A | 100% |  | R2 | 7896h | 7896h | LTE_MC_load | 34 | ZTE |  | Rel-13 | 67 |  |
| 3873 | 1495.1 | Core part: Multicarrier Load Distribution of UEs in LTE | 197d? | 2015-03-16 A | 2015-12-15 A | 100% | finish no earlier than 2015-12-15 | R2 | 1576h | 1576h | LTE_MC_load-Core | 34 | ZTE |  | Rel-13 | 67 | RP-151190 |
| 3874 | 1495.2 | Perf. part: Multicarrier Load Distribution of UEs in LTE | 395d? | 2015-03-16 A | 2016-09-15 A | 100% | finish no earlier than 2016-09-15 | R4 | 3160h | 3160h | LTE_MC_load-Perf | 34 | ZTE |  | Rel-13 | 67 | RP-151190 |
| 3875 | 1496 | **LTE-WLAN Radio Level Integration and Interworking Enhancement** | 916d? | 2015-03-16 A | 2018-09-14 A | 100% |  | R2 | 16760h | 16760h | LTE_WLAN_radio | 34 | Intel |  | Rel-13 | 67 |  |
| 3876 | 1496.1 | Core part: LTE-WLAN Radio Level Integration and Interworking Enhancement | 262d? | 2015-03-16 A | 2016-03-15 A | 100% | finish no earlier than 2016-03-15 | R2 | 2096h | 2096h | LTE_WLAN_radio-Core | 34 | Intel |  | Rel-13 | 67 | RP-151563 |
| 3877 | 1496.2 | Perf. part: LTE-WLAN Radio Level Integration and Interworking Enhancement | 262d? | 2015-03-16 A | 2016-03-15 A | 100% | finish no earlier than 2016-03-15 | R4 | 2096h | 2096h | LTE_WLAN_radio-Perf | 34 | Intel |  | Rel-13 | 67 | RP-151563 |
| 3878 | 1496.3 | UE Conformance Test Aspects - WLAN/3GPP Radio Level Integration and Interworking Enhancement Interworking | 655d? | 2016-03-15 A | 2018-09-14 A | 100% | finish no earlier than 2018-09-15 | R5 | 5240h | 5240h | LTE_WLAN_radio-UEConTest | 36 | Intel |  | Rel-13 | 71 |  |
| 3879 | 1497 | **RAN aspects for improvements to CS/PS coordination in UTRAN Shared Network** | 197d? | 2015-03-16 A | 2015-12-15 A | 100% |  | R3 | 3152h | 3152h | CSPS_Coord-UTRA | 34 | Ericsson |  | Rel-13 | 67 |  |
| 3880 | 1497.1 | Core part: RAN aspects for improvements to CS/PS coordination in UTRAN Shared Network | 197d? | 2015-03-16 A | 2015-12-15 A | 100% | finish no earlier than 2015-12-15 | R3 | 1576h | 1576h | CSPS_Coord-UTRA-Core | 34 | Ericsson |  | Rel-13 | 67 | RP-151289 |
| 3881 | 1498 | **LTE DL 4 Rx antenna ports** | 4639d? | 2000-01-03 A | 2017-09-15 A | 100% |  | R4 | 77392h | 77392h | LTE_4Rx_AP_DL | 34 | Ericsson |  | Rel-13 | 67 |  |
| 3882 | 1498.1 | Core part: LTE DL 4 Rx antenna ports | 197d? | 2015-03-16 A | 2015-12-15 A | 100% | finish no earlier than 2015-12-15 | R4 | 1576h | 1576h | LTE_4Rx_AP_DL-Core | 34 | Ericsson |  | Rel-13 | 67 | RP-151265 |
| 3883 | 1498.2 | Perf. part: LTE DL 4 Rx antenna ports | 4378d? | 2000-01-03 A | 2016-09-15 A | 100% | finish no earlier than 2016-09-15 | R4 | 35024h | 35024h | LTE_4Rx_AP_DL-Perf | 34 | Ericsson |  | Rel-13 | 67 | RP-151265 |
| 3884 | 1498.3 | UE Conformance Test Aspects - LTE DL 4 Rx antenna ports | 460d? | 2015-12-15 A | 2017-09-15 A | 100% | finish no earlier than 2017-09-15 | R5 | 3680h | 3680h | LTE_4Rx_AP_DL-UEConTest | 36 | Ericsson |  | Rel-13 | 70 |  |
| 3885 | 1499 | **AWS-Extension Band for LTE** | 395d? | 2015-03-16 A | 2016-09-15 A | 100% |  | R4 | 7904h | 7904h | LTE_AWS_EXT | 34 | Ericsson |  | Rel-13 | 67 |  |
| 3886 | 1499.1 | Core part: AWS-Extension Band for LTE | 197d? | 2015-03-16 A | 2015-12-15 A | 100% | finish no earlier than 2015-12-15 | R4 | 1576h | 1576h | LTE_AWS_EXT-Core | 34 | Ericsson |  | Rel-13 | 67 | RP-151343 |
| 3887 | 1499.2 | Perf. part: AWS-Extension Band for LTE | 197d? | 2015-03-16 A | 2015-12-15 A | 100% | finish no earlier than 2015-12-15 | R4 | 1576h | 1576h | LTE_AWS_EXT-Perf | 34 | Ericsson |  | Rel-13 | 67 | RP-151343 |
| 3888 | 1499.3 | UE Conformance Test Aspects - AWS-Extension Band for LTE (Band 66) | 199d? | 2015-12-15 A | 2016-09-15 A | 100% | finish no earlier than 2016-09-15 | R5 | 1592h | 1592h | LTE_AWS_EXT-UEConTest | 36 | Ericsson |  | Rel-13 | 70 |  |
| 3889 | 1500 | **Additional bandwidth combination set for LTE Advanced inter-band Carrier Aggregation of Band 5 and Band 7** | 66d? | 2015-03-16 A | 2015-06-15 A | 100% |  | R4 | 1584h | 1584h | LTE_CA_B5_B7_BWset | 34 | Nokia Networks |  | Rel-13 | 67 |  |
| 3890 | 1500.1 | Core part: Additional bandwidth combination set for LTE Advanced inter-band Carrier Aggregation of Band 5 and Band 7 | 66d? | 2015-03-16 A | 2015-06-15 A | 100% | finish no earlier than 2015-06-15 | R4 | 528h | 528h | LTE_CA_B5_B7_BWset-Core | 34 | Nokia Networks |  | Rel-13 | 67 | RP-150536 |
| 3891 | 1500.2 | Perf. part: Additional bandwidth combination set for LTE Advanced inter-band Carrier Aggregation of Band 5 and Band 7 | 66d? | 2015-03-16 A | 2015-06-15 A | 100% | finish no earlier than 2015-06-15 | R4 | 528h | 528h | LTE_CA_B5_B7_BWset-Perf | 34 | Nokia Networks |  | Rel-13 | 67 | RP-150536 |

Notes:
- 3868: 1st Apr 15: Compl:0%->10% 1st Apr 15: CD:Mon 15/06/15->Tue 15/03/16 1st Apr 15: Stat Rep: ->RP-150061 03/07/15: Compl:10%->20% 03/07/15: Stat Rep: RP-150061->RP-150584 29/09/15: Compl:20%->30% 29/09/15: Stat Rep: RP-150584->RP-151171
- 3870: 03/07/15: Compl:0%->25% 03/07/15: Stat Rep: ->RP-150744 29/09/15: Compl:25%->55% 29/09/15: Stat Rep: RP-150744->RP-151330 1/1/16: Compl:55%->100%
- 3871: 03/07/15: Stat Rep: ->RP-150744 29/09/15: Stat Rep: RP-150744->RP-151330 ¦1/1/16: WID: RP-150490->RP-15173922/3/16: Compl:0%->50%;
- 3873: 03/07/15: Compl:0%->40% 03/07/15: WID: RP-150491->RP-150611 03/07/15: Stat Rep: ->RP-150610 29/09/15: Compl:40%->55% 29/09/15: WID: RP-150611->RP-151206 29/09/15: Stat Rep: RP-150610->RP-151190
- 3874: 03/07/15: WID: RP-150491->RP-150611 03/07/15: Stat Rep: ->RP-150610 29/09/15: WID: RP-150611->RP-151206 29/09/15: Stat Rep: RP-150610->RP-1511901/1/16:22/3/16: Compl:70%->75%¦26/9/16: Compl:90%->100%¦26/9/16: WID: RP-152181
- 3876: 03/07/15: Compl:0%->30% 03/07/15: WID: RP-150510->RP-151114 03/07/15: Stat Rep: ->RP-151081, 07/08/15: impacted TSs added 29/09/15: Compl:30%->35% 29/09/15: Stat Rep: RP-151081->RP-151563; / Impacted TSs and TRs: 36.461; 36.462; 36.463; 36.464; 36.465; 36.622; 36.623; 36.624; 36.625; 36.360
- 3877: 03/07/15: WID: RP-150510->RP-151114 03/07/15: Stat Rep: ->RP-151081 29/09/15: Stat Rep: RP-151081->RP-1515631/1/16: Compl:0%->10% ¦22/3/16: Compl:10%->100%¦
- 3878: testing REL-13 LTE_WLAN_radio-Core¦1/7/16: Compl:0%->5%¦20/21/3/17: Compl:20 ;27/3/18: ;¦26/3/19: 58%->100
- 3880: 03/07/15: Compl:0%->45% 03/07/15: Stat Rep: ->RP-150842 29/09/15: Compl:45%->80% 29/09/15: CD:Tue 15/09/15->Tue 15/12/15 29/09/15: Stat Rep: RP-150842->RP-1512891/1/16: Compl:80%->100%
- 3882: 03/07/15: Compl:0%->25% 03/07/15: Stat Rep: ->RP-150803 29/09/15: Compl:25%->50% 29/09/15: Stat Rep: RP-150803->RP-151265¦1/1/16: Compl:50%->100%
- 3883: 03/07/15: Compl:0%->15% 03/07/15: CD:Mon 02/10/00->Wed 15/06/16 03/07/15: Stat Rep: ->RP-150803 29/09/15: Compl:15%->35% 29/09/15: Stat Rep: RP-150803->RP-15126522/3/16: Compl:60%-;26/9/16: Compl:90%->100%
- 3884: ¦22/3/16: Compl:0%->10%¦1/7/16: Compl:10%->25%¦ 26/9/16: 21/3/17: Compl:60%->70 ;
- 3886: 03/07/15: Compl:0%->20% 03/07/15: WID: RP-150428->RP-150800 03/07/15: Stat Rep: ->RP-150796 29/09/15: Compl:20%->50% 29/09/15: Stat Rep: RP-150796->RP-151343
- 3887: 03/07/15: WID: RP-150428->RP-150800 03/07/15: Stat Rep: ->RP-150796 29/09/15: Stat Rep: RP-150796->RP-151343¦
- 3888: ¦22/3/16: Compl:0%->10%1/7/16: Compl:10%->65%26/9/16: Comp
- 3890: 03/07/15: Compl:0%->100% 03/07/15: WID: RP-150171->RP-150602 03/07/15: Stat Rep: ->RP-150536
- 3891: 03/07/15: Compl:0%->100% 03/07/15: WID: RP-150171->RP-150602 03/07/15: Stat Rep: ->RP-150536

| ID | WBS | Task | Duration | Start | Finish | Complete | Constraint | Resources | Work | Actual work | Acronym | PCG approved | WI rapporteur name | Release | TSG approved | Status Report | WI rapporteur e-mail | TSG stopped |
| --- | --- | --- | --- | --- | --- | --- | --- | --- | --- | --- | --- | --- | --- | --- | --- | --- | --- | --- |
| 3892 | 1501 | **Additional bandwidth combination set for LTE Advanced inter-band Carrier Aggregation of Band 3 and Band 5** | 66d? | 2015-03-16 A | 2015-06-15 A | 100% |  | R4 | 1584h | 1584h | LTE_CA_B3_B5_BWset | 34 | Samsung | Rel-13 | 67 |  |  |  |
| 3893 | 1501.1 | Core part: Additional bandwidth combination set for LTE Advanced inter-band Carrier Aggregation of Band 3 and Band 5 | 66d? | 2015-03-16 A | 2015-06-15 A | 100% | finish no earlier than 2015-06-15 | R4 | 528h | 528h | LTE_CA_B3_B5_BWset-Core | 34 | Samsung | Rel-13 | 67 | RP-150536 |  |  |
| 3894 | 1501.2 | Perf. part: Additional bandwidth combination set for LTE Advanced inter-band Carrier Aggregation of Band 3 and Band 5 | 66d? | 2015-03-16 A | 2015-06-15 A | 100% | finish no earlier than 2015-06-15 | R4 | 528h | 528h | LTE_CA_B3_B5_BWset-Perf | 34 | Samsung | Rel-13 | 67 | RP-150536 |  |  |
| 3895 | 1502 | **Multiflow Enhancements for UTRA** | 132d? | 2015-03-16 A | 2015-09-15 A | 100% |  | R2 | 2112h | 2112h | HSDPA_MFTX_enh | 34 | Nokia | Rel-13 | 67 |  | alexander.sayenko@nokia.com |  |
| 3896 | 1502.1 | Core part: Multiflow Enhancements for UTRA | 132d? | 2015-03-16 A | 2015-09-15 A | 100% | finish no earlier than 2015-09-15 | R2 | 1056h | 1056h | HSDPA_MFTX_enh-Core | 34 | Nokia | Rel-13 | 67 | RP-151302 | alexander.sayenko@nokia.com |  |
| 3897 | 1503 | **Message interworking during PS to CS SRVCC** | 68d? | 2015-06-15 A | 2015-09-16 A | 100% |  | C1 | 1632h | 1632h | mSRVCC | 35 | Ivo Sedlacek, Ericsson | Rel-13 | 68 |  | ivo.sedlacek@ericsson.com |  |
| 3898 | 1503.1 | CT1 aspects of Message interworking during PS to CS SRVCC | 68d? | 2015-06-15 A | 2015-09-16 A | 100% | start no earlier than 2015-06-15 | C1 | 544h | 544h | mSRVCC | 35 | Ivo Sedlacek, Ericsson | Rel-13 | 68 |  | ivo.sedlacek@ericsson.com |  |
| 3899 | 1503.2 | CT3 aspects of Message interworking during PS to CS SRVCC | 68d? | 2015-06-15 A | 2015-09-16 A | 100% | finish no earlier than 2015-09-16 | C3 | 544h | 544h | mSRVCC | 35 | Ivo Sedlacek, Ericsson | Rel-13 | 68 |  | ivo.sedlacek@ericsson.com |  |
| 3900 | 1504 | **Support of Emergency services over WLAN – phase 1** | 192d? | 2015-06-18 A | 2016-03-11 A | 100% |  | S2 | 5896h | 5896h | SEW1 | 35 | Laurent thiebaut | Rel-13 | 68 |  | Laurent.thiebaut@alcatel-lucent.com |  |
| 3901 | 1504.1 | Stage 2 of Support of Emergency services over WLAN - phase 1 | 65d? | 2015-06-18 A | 2015-09-16 A | 100% | finish no earlier than 2015-09-16 | S2 | 520h | 520h | SEW1 | 35 | Laurent thiebaut | Rel-13 | 68 |  | Laurent.thiebaut@alcatel-lucent.com |  |
| 3902 | 1504.2 | **CT aspects of Support of Emergency services over WLAN – phase 1** | 135d? | 2015-09-07 A | 2016-03-11 A | 100% |  | ct | 3840h | 3840h | SEW1-CT | 35 | Alcatel-Lucent, Jennifer Liu (CT1) | Rel-13 | 69 |  | jennifer.liu@alcatel-lucent.com |  |
| 3903 | 1504.2.1 | CT1 aspects of Support of Emergency services over WLAN – phase 1 | 135d? | 2015-09-07 A | 2016-03-11 A | 100% | finish no earlier than 2016-03-11 | C1 | 1080h | 1080h | SEW1-CT | 35 | Alcatel-Lucent, Jennifer Liu (CT1) | Rel-13 | 69 |  | jennifer.liu@alcatel-lucent.com |  |
| 3904 | 1504.2.2 | CT3 aspects of Support of Emergency services over WLAN – phase 1 | 70d? | 2015-09-07 A | 2015-12-11 A | 100% | finish no earlier than 2015-12-11 | C3 | 560h | 560h | SEW1-CT | 35 | Alcatel-Lucent, Jennifer Liu (CT1) | Rel-13 | 69 |  | jennifer.liu@alcatel-lucent.com |  |
| 3905 | 1504.2.3 | CT4 aspects of Support of Emergency services over WLAN – phase 1 | 70d? | 2015-09-07 A | 2015-12-11 A | 100% | finish no earlier than 2015-12-11 | C4 | 560h | 560h | SEW1-CT | 35 | Alcatel-Lucent, Jennifer Liu (CT1) | Rel-13 | 69 |  | jennifer.liu@alcatel-lucent.com |  |
| 3906 | 1504.2.4 | CT6 aspects of Support of Emergency services over WLAN – phase 1 | 70d? | 2015-09-07 A | 2015-12-11 A | 100% | finish no earlier than 2015-12-11 | C6 | 560h | 560h | SEW1-CT | 35 | Alcatel-Lucent, Jennifer Liu (CT1) | Rel-13 | 69 |  | jennifer.liu@alcatel-lucent.com |  |
| 3907 | 1505 | **MBMS Enhancements** | 264d? | 2014-12-03 A | 2015-12-07 A | 100% |  | S2 | 4320h | 4320h | MBMS_enh | 34 | Nokia Networks, Curt Wong | Rel-13 | 66 |  |  |  |
| 3908 | 1505.1 | MBMS Enhancements TR Phase | 204d? | 2014-12-03 A | 2015-09-14 A | 100% | finish no earlier than 2015-09-14 | S2 | 1632h | 1632h | FS_MBMS_enh_TR | 34 | Nokia Networks, Curt Wong | Rel-13 | 66 |  |  |  |
| 3909 | 1505.2 | MBMS Enhancements | 28d? | 2015-08-10 A | 2015-09-16 A | 100% | finish no earlier than 2015-09-16 | S2 | 224h | 224h | MBMS_enh_St2 | 35 | Nokia Networks, Curt Wong | Rel-13 | 69 |  |  |  |
| 3910 | 1505.3 | **CT aspects of MBMS Enhancements** | 21d? | 2015-11-09 A | 2015-12-07 A | 100% |  | C3 | 344h | 344h | MBMS_enh-CT | 36 | Nokia Networks, Thomas Belling | Rel-13 | 70 |  |  |  |
| 3911 | 1505.3.1 | CT3 aspects of MBMS enhancements | 21d? | 2015-11-09 A | 2015-12-07 A | 100% | start no earlier than 2015-11-09 | C3 | 168h | 168h | MBMS_enh-CT | 36 | Nokia Networks, Thomas Belling | Rel-13 | 70 |  |  |  |
| 3912 | 1505.3.2 | CT4 aspects of MBMS enhancements | 21d? | 2015-11-09 A | 2015-12-07 A | 100% | finish no earlier than 2015-12-07 | C4 | 168h | 168h | MBMS_enh-CT | 36 | Nokia Networks, Thomas Belling | Rel-13 | 70 |  |  |  |
| 3913 | 1505.4 | Deleted (not approved) - MBMS Enhancements - Stage 2 | 1d? | 2015-03-13 A | 2015-03-13 A | 100% | finish no earlier than 2015-03-13 | S2 | 8h | 8h | MBMS_enh_TS | 34 | Rainer Liebhart | Rel-13 | 66 |  |  | SP-69 |
| 3914 | 1506 | **EPC Signalling Improvements for race scenarios** | 135d? | 2015-09-07 A | 2016-03-11 A | 100% |  | C4 | 2760h | 2760h | EPC_SIG_RACE | 35 | Huawei, Peter Schmitt | Rel-13 | 69 |  | Huawei, Peter Schmitt, Peter.Schmitt@HUAWEI.COM |  |
| 3915 | 1506.1 | CT3 aspects for EPC Signalling Improvements for race scenarios | 135d? | 2015-09-07 A | 2016-03-11 A | 100% | finish no earlier than 2016-03-11 | C3 | 1080h | 1080h | EPC_SIG_RACE | 35 | Huawei, Peter Schmitt | Rel-13 | 69 |  | Huawei, Peter Schmitt, Peter.Schmitt@HUAWEI.COM |  |
| 3916 | 1506.2 | CT4 aspects for EPC Signalling Improvements for race scenarios | 75d? | 2015-09-07 A | 2015-12-18 A | 100% | finish no earlier than 2015-12-18 | C4 | 600h | 600h | EPC_SIG_RACE | 35 | Huawei, Peter Schmitt | Rel-13 | 69 |  | Huawei, Peter Schmitt, Peter.Schmitt@HUAWEI.COM |  |

Notes:
- 3893: 03/07/15: Compl:0%->100% 03/07/15: Stat Rep: ->RP-150536
- 3894: 03/07/15: Compl:0%->100% 03/07/15: Stat Rep: ->RP-150536
- 3896: 03/07/15: Compl:0%->80% 03/07/15: WID: RP-150288->RP-151021 03/07/15: Stat Rep: ->RP-150827 29/09/15: Compl:80%->100% 29/09/15: Stat Rep: RP-150827->RP-151302
- 3898: 07/09/15: 0%->25¦7/12/15: 25%->100 / Impacted TSs and TRs: 24.237; 24.292
- 3899: 07/09/15: 0%->70¦7/12/15: 70%->100 / Impacted TSs and TRs: 29.292
- 3900: 07/09/15: 0%->100 / Impacted TSs and TRs: 23.402; 23.167; 23.271; 23.203; 23.228
- 3901: 07/09/15: 0%->100 / Impacted TSs and TRs: 23.402; 23.167; 23.271; 23.203; 23.228
- 3903: 7/12/15: 60%->95. FCD -> 03/16, ES in CP-150729¦7/3/16: 95%->100 / Impacted TSs and TRs: 24.302; 24.229
- 3904: 7/12/15: 0%->100 / Impacted TSs and TRs: 29.212; 29.214
- 3905: 7/12/15: 0%->100 / Impacted TSs and TRs: 23.003; 23.008; 29.273; 29.274
- 3906: 7/3/16: 0%->100 / Impacted TSs and TRs: 31.102
- 3907: . 3/3: WID tdoc number updated¦14/09/15: WID:SP-140883->SP-150516
- 3908: Acronym changed from "MBMS_enh-SA2TR". Mar15: 0->10%¦June2015: Compl:10%->50¦07/09/15: 50%->70. acronym changed from "MBMS_enh" to "MBMS_enh_TR"¦07/09/15: 70%->100¦14/09/15: WID:SP-140883->SP-150516 / Impacted TSs and TRs: 23.8xy
- 3909: SA#69: no normative work, moved as Study only. 14/10/15: corrected: was mentioned as FS_ / Impacted TSs and TRs: 23.246; 23.468
- 3911: 8/12/15: 0%->100 / Impacted TSs and TRs: 29.061; 29.468
- 3912: Impacted TSs and TRs: 29.274; 23.008; 29.230
- 3913: Commented during RAN#67 that it should have never beeen here. 07/09/15: "undeleted", acronym changed from "MBMS_enh-del" to "MBMS_enh_TS". 14/10/15: SP-140883 was never approved so this line should have never appeared in the WP. / Impacted TSs and TRs: 23.246; 23.468
- 3915: 7/12/15: FCD -> 03/16, ES in CP-150861¦8/12/15: 0%->100 / Impacted TSs and TRs: 29.212; 29.213
- 3916: 7/12/15: 95%->100 / Impacted TSs and TRs: 29.274; 29.274; 29.275; 29.282; 29.273; 29.230; 23.008; 29.273

| ID | WBS | Task | Duration | Start | Finish | Complete | Remaining | Total slack | Constraint | Resources | Work | Actual work | Acronym | PCG approved | WI rapporteur name | WI rapporteur e-mail | Release | TSG approved | Status Report |
| --- | --- | --- | --- | --- | --- | --- | --- | --- | --- | --- | --- | --- | --- | --- | --- | --- | --- | --- | --- |
| 3917 | 1507 | **Diameter Message Priority** | 164d? | 2015-11-02 A | 2016-06-16 A | 100% |  |  |  | C4 | 3736h | 3736h | DiaPri | 36 | Alcatel-Lucent, Jean-Jacques Trottin | jean-jacques.trottin@alcatel-lucent.com | Rel-13 | 70 |  |
| 3918 | 1507.1 | CT3 aspects of DiaPri | 95d? | 2015-11-02 A | 2016-03-11 A | 100% |  |  | finish no earlier than 2016-03-11 | C3 | 760h | 760h | DiaPri | 36 | Intel, Vivek Gupta |  | Rel-13 | 70 |  |
| 3919 | 1507.2 | CT4 aspects of DiaPri | 95d? | 2015-11-02 A | 2016-03-11 A | 100% |  |  | finish no earlier than 2016-03-11 | C4 | 760h | 760h | DiaPri | 36 | Alcatel-Lucent, Jean-Jacques Trottin | jean-jacques.trottin@alcatel-lucent.com | Rel-13 | 70 |  |
| 3920 | 1507.3 | (IETF) Diameter Routing Message Priority (draft-ietf-dime-drmp) | 138d? | 2015-12-08 A | 2016-06-16 A | 100% |  |  | finish no earlier than 2016-06-16 | C4-IETF | 1104h | 1104h | DiaPri | 36 | Alcatel-Lucent, Jean-Jacques Trottin | jean-jacques.trottin@alcatel-lucent.com | Rel-13 | 71 |  |
| 3921 | 1508 | **Downlink TPC Enhancements for UMTS** | 197d? | 2015-06-15 A | 2016-03-15 A | 100% |  |  |  | R1 | 4208h | 4208h | UTRA_EDL_TPC | 35 | Huawei |  | Rel-13 | 68 |  |
| 3922 | 1508.1 | Core part: Downlink TPC Enhancements for UMTS | 44d? | 2015-10-15 A | 2015-12-15 A | 100% |  |  | finish no earlier than 2015-12-15 | R1; R2; R3 | 1056h | 1056h | UTRA_EDL_TPC-Core | 35 | Huawei |  | Rel-13 | 68 | RP-151564 |
| 3923 | 1508.2 | Perf. part: Downlink TPC Enhancements for UMTS | 197d? | 2015-06-15 A | 2016-03-15 A | 100% |  |  | finish no earlier than 2016-03-15 | R4 | 1576h | 1576h | UTRA_EDL_TPC-Perf | 35 | Huawei |  | Rel-13 | 68 | RP-151564 |
| 3924 | 1509 | **Licensed-Assisted Access using LTE** | 591d? | 2015-06-15 A | 2017-09-15 | 99% | 0d? | 0d |  | R1 | 12624h | 8599.11h | LTE_LAA | 35 | Ericsson |  | Rel-13 | 68 |  |
| 3925 | 1509.1 | Core part: Licensed-Assisted Access using LTE | 132d? | 2015-06-15 A | 2015-12-15 A | 100% |  |  | finish no earlier than 2015-12-15 | R1 | 1056h | 1056h | LTE_LAA-Core | 35 | Ericsson |  | Rel-13 | 68 | RP-151390 |
| 3926 | 1509.2 | Perf. part: Licensed-Assisted Access using LTE | 395d? | 2015-06-15 A | 2016-12-15 A | 100% |  |  | finish no earlier than 2016-12-15 | R4 | 3160h | 3160h | LTE_LAA-Perf | 35 | Ericsson |  | Rel-13 | 68 |  |
| 3927 | 1509.3 | UE Conformance Test Aspects - Licensed-Assisted Access using LTE | 460d? | 2015-12-15 A | 2017-09-15 A | 100% |  |  | finish no earlier than 2017-09-15 | R5 | 3680h | 3680h | LTE_LAA-UEConTest | 36 | Motorola Mobility |  | Rel-13 | 70 |  |
| 3928 | 1510 | **Elevation Beamforming/Full-Dimension (FD) MIMO for LTE** | 916d? | 2015-06-15 A | 2018-12-14 | 99% | 0d? | 0d |  | R1 | 13632h | 8944h | LTE_EBF_FDMIMO | 35 | Samsung |  | Rel-13 | 68 |  |
| 3929 | 1510.1 | Core part: Elevation Beamforming/Full-Dimension (FD) MIMO for LTE | 132d? | 2015-06-15 A | 2015-12-15 A | 100% |  |  | finish no earlier than 2015-12-15 | R1 | 1056h | 1056h | LTE_EBF_FDMIMO-Core | 35 | Samsung |  | Rel-13 | 68 | RP-151565 |
| 3930 | 1510.2 | Perf. part: Elevation Beamforming/Full-Dimension (FD) MIMO for LTE | 330d? | 2015-06-15 A | 2016-09-15 A | 100% |  |  | finish no earlier than 2016-09-15 | R4 | 2640h | 2640h | LTE_EBF_FDMIMO-Perf | 35 | Samsung |  | Rel-13 | 68 | RP-151565 |
| 3931 | 1510.3 | UE Conformance Test Aspects - Elevation Beamforming/Full-Dimension MIMO for LTE | 326d? | 2017-09-15 A | 2018-12-14 A | 100% |  |  | finish no earlier than 2018-12-15 | R5 | 2608h | 2608h | LTE_EBF_FDMIMO-UEConTest | 39 | Ericsson |  | Rel-13 | 77 |  |
| 3932 | 1511 | **L2/L3 Downlink enhancements for UMTS** | 132d? | 2015-06-15 A | 2015-12-15 A | 100% |  |  |  | R2 | 2112h | 2112h | UTRA_EDL_L23 | 35 | Huawei |  | Rel-13 | 68 |  |
| 3933 | 1511.1 | Core part: L2/L3 Downlink enhancements for UMTS | 132d? | 2015-06-15 A | 2015-12-15 A | 100% |  |  | finish no earlier than 2015-12-15 | R2 | 1056h | 1056h | UTRA_EDL_L23-Core | 35 | Huawei |  | Rel-13 | 68 | RP-151238 |
| 3934 | 1512 | **Support of single-cell point-to-multipoint transmission in LTE** | 330d? | 2015-06-15 A | 2016-09-15 A | 100% |  |  |  | R2 | 5824h | 5824h | LTE_SC_PTM | 35 | Huawei |  | Rel-13 | 68 |  |
| 3935 | 1512.1 | Core part: Support of single-cell point-to-multipoint transmission in LTE | 132d? | 2015-06-15 A | 2015-12-15 A | 100% |  |  | finish no earlier than 2015-12-15 | R2 | 1056h | 1056h | LTE_SC_PTM-Core | 35 | Huawei |  | Rel-13 | 68 | RP-151237 |
| 3936 | 1512.2 | Perf. part: Support of single-cell point-to-multipoint transmission in LTE | 132d? | 2015-06-15 A | 2015-12-15 A | 100% |  |  | finish no earlier than 2016-06-15 | R4 | 1056h | 1056h | LTE_SC_PTM-Perf | 35 | Huawei |  | Rel-13 | 68 | RP-151237 |
| 3937 | 1512.3 | UE Conformance Test Aspects - Support of single-cell point-to-multipoint transmission in LTE | 134d? | 2016-03-15 A | 2016-09-15 A | 100% |  |  | finish no earlier than 2016-12-15 | R5 | 1072h | 1072h | LTE_SC_PTM-UEConTest | 36 | Huawei |  | Rel-13 | 71 |  |
| 3938 | 1513 | **Extension of Dual Connectivity in E-UTRAN** | 132d? | 2015-06-15 A | 2015-12-15 A | 100% |  |  |  | R3 | 2112h | 2112h | LTE_dualC_ext | 35 | Samsung |  | Rel-13 | 68 |  |
| 3939 | 1513.1 | Core part: Extension of Dual Connectivity in E-UTRAN | 132d? | 2015-06-15 A | 2015-12-15 A | 100% |  |  | finish no earlier than 2015-12-15 | R3 | 1056h | 1056h | LTE_dualC_ext-Core | 35 | Samsung |  | Rel-13 | 68 | RP-151214 |
| 3940 | 1514 | **RAN sharing enhancements for UMTS** | 132d? | 2015-06-15 A | 2015-12-15 A | 100% |  |  |  | R3 | 2112h | 2112h | RSE_UTRA_GUSH | 35 | Huawei |  | Rel-13 | 68 |  |
| 3941 | 1514.1 | Core part: RAN sharing enhancements for UMTS | 132d? | 2015-06-15 A | 2015-12-15 A | 100% |  |  | finish no earlier than 2015-12-15 | R3 | 1056h | 1056h | RSE_UTRA_GUSH-Core | 35 | Huawei |  | Rel-13 | 68 | RP-151239 |

Notes:
- 3918: ES in CP-150645¦7/3/16: 65%->100 / Impacted TSs and TRs: 29.153; 29.154; 29.201; 29.212; 29.213; 29.214; 29.215; 29.217; 29.219
- 3919: ES in CP-150622¦7/3/16: 70%->100 / Impacted TSs and TRs: 29.228; 29.229; 29.272; 29.273; 29.328; 29.329; 29.336; 29.337; 29.338; 29.344; 29.345
- 3920: 02/2016: publication requested¦2/12/16: 85%->100; 9/4/21: RFC 7944 added; 7/3/16:introducedbyIETFinputs / Impacted TSs and TRs: 29.227; 29.272; 29.273; 29.229; RFC 7944
- 3921: follow-up WI of REL-13 SI FS_UTRA_EDL¦TPC = Transmit Power Control
- 3922: follow-up WI of REL-13 SI FS_UTRA_EDL¦TPC = Transmit Power Control 29/09/15: Compl:0%->35% 29/09/15: Stat Rep: -->RP-1515641/1/16: Compl:35%->100%1/1/16: WID:
- 3923: follow-up WI of REL-13 SI FS_UTRA_EDL¦TPC = Transmit Power Control 29/09/15: Stat Rep: -->RP-151564¦1/1/16: Compl:0%->80%¦1/1/16: WID: RP-151044->RP-151880
- 3924: follow-up WI of REL-13 SI FS_LTE_LAA
- 3925: follow-up WI of REL-13 SI FS_LTE_LAA 29/09/15: Compl:0%->25% 29/09/15: Stat Rep: -->RP-1513901/1/16: Compl:25%->100%
- 3926: follow-up WI of REL-13 SI FS_LTE_LAA 29/09/15: Stat Rep: -->RP-15139022/3/16: Compl:0%->33%¦1/7/16: Compl:3¦26/9/16: Compl:50%->90%¦20/12/16: Compl:90%->100%¦20/12/16: Stat Rep: RP-151390->
- 3927: ¦22/3/16: Compl:0%->5%1/7/16: Compl:5%->8%26/9/16: Compl:8%->15%¦20/21/3/17: Com ;
- 3928: follow-up WI of REL-13 SI FS_LTE_EBF_FDMIMO
- 3929: follow-up WI of REL-13 SI FS_LTE_EBF_FDMIMO 29/09/15: Compl:0%->25% 29/09/15: Stat Rep: -->RP-151565 1/1/16: Compl:25%->100%
- 3930: follow-up WI of REL-13 SI FS_LTE_EBF_FDMIMO 29/09/15: Stat Rep: -->RP-151565 ¦1/1/16: Compl:0%->5%¦22/3/16: Compl:5%->35%;26/9/16: Compl:70%->100%
- 3931: ¦8/1/18: Compl:0%->5%¦27/3/18: Compl:5%->10%¦27/6/18: CD:Fri 15/06/18-; 26/3/20: 10%->100
- 3932: no Perf. part¦follow-up of Rel-13 SI FS_UTRA_EDL
- 3933: no Perf. part¦follow-up of Rel-13 SI FS_UTRA_EDL 29/09/15: Compl:0%->35% 29/09/15: WID: RP-151043->RP-151249 29/09/15: Stat Rep: -->RP-1512381/1/16: Compl:35%->100% ¦
- 3934: follow-up WI of REL-13 SI FS_LTE_SC_PTM
- 3935: follow-up WI of REL-13 SI FS_LTE_SC_PTM 29/09/15: Compl:0%->30% 29/09/15: Stat Rep: -->RP-151237 1/1/16: Compl:30%->100%
- 3936: follow-up WI of REL-13 SI FS_LTE_SC_PTM 29/09/15: Stat Rep: -->RP-1512371/1/16: Compl:0%->100%
- 3937: testing REL-13 LTE_SC_PTM-Core1/7/16: Compl:0%->40%26/9/16
- 3938: no Perf. part¦follow-up WI of REL-13 SI FS_LTE_dualC_ext;
- 3939: no Perf. part¦follow-up WI of REL-13 SI FS_LTE_dualC_ext¦29/09/15: Compl:0%->30% 29/09/15: Stat Rep: -->RP-151214¦1/1/16: Compl:3
- 3940: no Perf. part¦follow-up WI for Rel-13 SI FS_RSE_UTRA_GUSH¦note: GUSH was a REL-13 SA1 WI¦there is an ongoing REL-13 WI for LTE: RSE-RAN_LTE;
- 3941: no Perf. part¦follow-up WI for Rel-13 SI FS_RSE_UTRA_GUSH¦note: GUSH was a REL-13 SA1 WI¦there is an ongoing REL-13 WI for LTE: RSE-RAN_LTE¦29/09/15: Compl:0%->30% 29/09/15: WID: RP-151086->RP-151251 29/09/15: Stat Rep: -->RP-151239 ¦

| ID | WBS | Task | Duration | Start | Finish | Complete | Constraint | Resources | Work | Actual work | Acronym | PCG approved | WI rapporteur name | Release | TSG approved | Status Report | Impacted TSs and TRs | WI rapporteur e-mail |
| --- | --- | --- | --- | --- | --- | --- | --- | --- | --- | --- | --- | --- | --- | --- | --- | --- | --- | --- |
| 3942 | 1515 | **Interference mitigation for downlink control channels of LTE** | 851d? | 2015-06-15 A | 2018-09-14 A | 100% |  | R4 | 12056h | 12056h | LTE_IM_DLCCH | 35 | Intel | Rel-13 | 68 |  |  |  |
| 3943 | 1515.1 | Perf. part: Interference mitigation for downlink control channels of LTE | 263d? | 2015-06-15 A | 2016-06-15 A | 100% | finish no earlier than 2016-06-15 | R4 | 2104h | 2104h | LTE_IM_DLCCH-Perf | 35 | Intel | Rel-13 | 68 | RP-151301 |  |  |
| 3944 | 1515.2 | UE Conformance Test Aspects - Interference Mitigation for Downlink Control Channels of LTE | 393d? | 2017-03-15 A | 2018-09-14 A | 100% | finish no earlier than 2018-09-15 | R5 | 3144h | 3144h | LTE_IM_DLCCH-UEConTest | 38 | Intel | Rel-13 | 75 |  |  |  |
| 3945 | 1516 | **Network-Assisted Interference Cancellation and Suppression for UMTS** | 66d? | 2015-09-15 A | 2015-12-15 A | 100% |  | R1 | 1056h | 1056h | UTRA_NAICS | 35 | Huawei | Rel-13 | 69 |  |  |  |
| 3946 | 1516.1 | Core part: Network-Assisted Interference Cancellation and Suppression for UMTS | 66d? | 2015-09-15 A | 2015-12-15 A | 100% | finish no earlier than 2015-12-15 | R1 | 528h | 528h | UTRA_NAICS-Core | 35 | Huawei | Rel-13 | 69 |  |  |  |
| 3947 | 1517 | **Dual Carrier HSUPA Enhancements for UTRAN CS** | 66d? | 2015-09-15 A | 2015-12-15 A | 100% |  | R2 | 1056h | 1056h | DC_HSUPA_CS | 35 | Nokia Networks | Rel-13 | 69 |  |  |  |
| 3948 | 1517.1 | Core part: Dual Carrier HSUPA Enhancements for UTRAN CS | 66d? | 2015-09-15 A | 2015-12-15 A | 100% | finish no earlier than 2015-12-15 | R2 | 528h | 528h | DC_HSUPA_CS-Core | 35 | Nokia Networks | Rel-13 | 69 |  |  |  |
| 3949 | 1518 | **Further Enhancements of Minimization of Drive Tests for E-UTRAN** | 524d? | 2015-03-16 A | 2017-03-15 A | 100% |  | R2 | 6304h | 6304h | LTE_eMDT2 | 35 | CMCC | Rel-13 | 69 |  |  |  |
| 3950 | 1518.1 | Study on further Enhancements of Minimization of Drive Tests for E-UTRAN | 132d? | 2015-03-16 A | 2015-09-15 A | 100% | finish no earlier than 2015-09-15 | R2 | 1056h | 1056h | FS_LTE_eMDT2 | 34 | CMCC | Rel-13 | 67 | RP-151181 | 36.880 |  |
| 3951 | 1518.2 | Core part: Further Enhancements of Minimization of Drive Tests for E-UTRAN | 66d? | 2015-09-15 A | 2015-12-15 A | 100% | finish no earlier than 2015-12-15 | R2 | 528h | 528h | LTE_eMDT2-Core | 35 | CMCC | Rel-13 | 69 |  |  |  |
| 3952 | 1518.3 | UE Conformance Test Aspects – Further Enhancements of Minimization of Drive Tests for E-UTRAN | 197d? | 2016-06-15 A | 2017-03-15 A | 100% | finish no earlier than 2017-03-15 | R5 | 1576h | 1576h | LTE_eMDT2-UEConTest | 37 | Intel | Rel-13 | 72 |  |  |  |
| 3953 | 1519 | **LTE-WLAN RAN Level Integration supporting legacy WLAN** | 131d? | 2015-09-15 A | 2016-03-15 A | 100% |  | R2 | 2096h | 2096h | LTE_WLAN_radio_legacy | 35 | Alcatel-Lucent | Rel-13 | 69 |  |  |  |
| 3954 | 1519.1 | Core part: LTE-WLAN RAN Level Integration supporting legacy WLAN | 131d? | 2015-09-15 A | 2016-03-15 A | 100% | finish no earlier than 2016-03-15 | R2 | 1048h | 1048h | LTE_WLAN_radio_legacy-Core | 35 | Alcatel-Lucent | Rel-13 | 69 |  | 36.361 |  |
| 3955 | 1520 | **Indoor Positioning enhancements for UTRA and LTE** | 393d? | 2015-09-15 A | 2017-03-15 A | 100% |  | R2 | 7152h | 7152h | UTRA_LTE_iPos_enh | 35 | NextNav | Rel-13 | 69 |  |  |  |
| 3956 | 1520.1 | Core part: Indoor Positioning enhancements for UTRA and LTE | 66d? | 2015-09-15 A | 2015-12-15 A | 100% | finish no earlier than 2015-12-15 | R2 | 528h | 528h | UTRA_LTE_iPos_enh-Core | 35 | NextNav | Rel-13 | 69 |  |  |  |
| 3957 | 1520.2 | Perf. part: Indoor Positioning enhancements for UTRA and LTE | 197d? | 2015-09-15 A | 2016-06-15 A | 100% | finish no earlier than 2016-06-15 | R4 | 1576h | 1576h | UTRA_LTE_iPos_enh-Perf | 35 | NextNav | Rel-13 | 69 |  | 37.171; 37.958 |  |
| 3958 | 1520.3 | **CT aspects of Indoor Positionning** | 41d? | 2015-10-12 A | 2015-12-07 A | 100% |  | C4 | 328h | 328h | UTRA_LTE_iPos_enh-CT | 36 | Ericsson, Jesús de Gregorio | Rel-13 | 70 |  | 29.171; 29.172; 29.230; 29.002 | jesus.de.gregorio@ericsson.com |
| 3959 | 1520.3.1 | CT4 aspects of Indoor Positionning | 41d? | 2015-10-12 A | 2015-12-07 A | 100% | finish no earlier than 2015-12-07 | C4 | 328h | 328h | UTRA_LTE_iPos_enh-CT | 36 | Ericsson, Jesús de Gregorio | Rel-13 | 70 |  | 29.171; 29.172; 29.230; 29.002 | jesus.de.gregorio@ericsson.com |
| 3960 | 1520.4 | UE Conformance Test Aspects – Indoor Positioning Enhancement Support for LTE and UMTS | 197d? | 2016-06-15 A | 2017-03-15 A | 100% | finish no earlier than 2017-06-15 | R5 | 1576h | 1576h | UTRA_LTE_iPos_enh-UEConTest | 37 | NextNav | Rel-13 | 72 |  |  |  |
| 3961 | 1521 | **Power saving enhancements for UMTS** | 197d? | 2015-06-15 A | 2016-03-15 A | 100% |  | R2 | 3160h | 3160h | UTRA_SDATA_POWSAV | 35 | Ericsson | Rel-13 | 68 |  |  |  |
| 3962 | 1521.1 | Core part: Power saving enhancements for UMTS | 132d? | 2015-06-15 A | 2015-12-15 A | 100% | finish no earlier than 2015-12-15 | R2 | 1056h | 1056h | UTRA_SDATA_POWSAV-Core | 35 | Ericsson | Rel-13 | 68 | RP-151291 |  |  |
| 3963 | 1521.2 | Perf. Part: Power saving enhancements for UMTS | 66d? | 2015-12-15 A | 2016-03-15 A | 100% | finish no earlier than 2016-03-15 | R4 | 528h | 528h | UTRA_SDATA_POWSAV-Perf | 36 | Ericsson | Rel-13 | 70 |  |  |  |
| 3964 | 1522 | **700MHz E-UTRA FDD Band for Arab Region** | 197d? | 2015-06-15 A | 2016-03-15 A | 100% |  | R4 | 4728h | 4728h | LTE_FDD_700_ARAB | 35 | Etisalat | Rel-13 | 68 |  |  |  |
| 3965 | 1522.1 | Core part: 700MHz E-UTRA FDD Band for Arab Region | 197d? | 2015-06-15 A | 2016-03-15 A | 100% | finish no earlier than 2016-03-15 | R4 | 1576h | 1576h | LTE_FDD_700_ARAB-Core | 35 | Etisalat | Rel-13 | 68 | RP-151207 | 36.893 |  |
| 3966 | 1522.2 | Perf. part: 700MHz E-UTRA FDD Band for Arab Region | 197d? | 2015-06-15 A | 2016-03-15 A | 100% | finish no earlier than 2016-03-15 | R4 | 1576h | 1576h | LTE_FDD_700_ARAB-Perf | 35 | Etisalat | Rel-13 | 68 | RP-151207 |  |  |

Notes:
- 3942: only Perf. part, no Core part;
- 3943: only Perf. part, no Core part¦29/09/15: CD:Tue 15/03/16->Wed 15/06/16 29/09/15: Stat Rep: -->RP-1513011/1/16: Compl:0%->40%22/3/16: Compl:40%->70%
- 3944: tested: REL-13 LTE_IM_DLCCH-Perf (note: WI had no Core part);19/6/171 8/1/18: C 27/3/18 ;¦26/3/19: 84%->100
- 3945: no Perf. part¦follow-up WI REL-13 RAN1 SI FS_UTRA_NAICS
- 3946: no Perf. part¦follow-up WI REL-13 RAN1 SI FS_UTRA_NAICS ¦1/1/16: Compl:0%->100% ¦1/1/16: WID: RP-151577->RP-151879
- 3947: no Perf. part¦compare REL-13 WI HSUPA_DB_MC
- 3948: no Perf. part¦compare REL-13 WI HSUPA_DB_MC 1/1/16: Compl:0%->100% 1/1/16: WID: RP-151607->RP-151780
- 3949: no Perf. part¦follow-up WI of REL-13 SI FS_LTE_eMDT2
- 3950: 03/07/15: Compl:0%->70% 03/07/15: Stat Rep: -->RP-150806 29/09/15: Compl:70%->100% 29/09/15: Stat Rep: RP-150806->RP-151181
- 3951: no Perf. part¦follow-up WI of REL-13 SI FS_LTE_eMDT2¦1/1/16: Compl:0%->100%
- 3952: tested REL-13 WI: LTE_eMDT2-Core26/9/16: Com;21/3/17: Compl:5%->100%
- 3953: no Perf. part¦compare REL-13 WI LTE_WLAN_radio
- 3954: no Perf. part¦compare REL-13 WI LTE_WLAN_radio1/1/16: Compl:0%->95% 22/3/16: Compl:95%->100%¦28/7/16: 36.361 added;
- 3955: follow-up WI of REL-13 SI FS_UTRA_LTE_iPos_enh
- 3956: follow-up WI of REL-13 SI FS_UTRA_LTE_iPos_enh1/1/16: Compl:0%->100%1/1/16: WID: RP-151624->RP-15225122/3/16: WID: RP-152251->RP-160332
- 3957: follow-up WI of REL-13 SI FS_UTRA_LTE_iPos_enh 1/1/16: Compl:0%->10% 1/1/16: WID: RP-151624->RP-152251¦22/3/16: Compl:10%->20%¦22/3/16: WID: RP-152251->RP-160332 28/7/16: 37.171 added¦28/7/16: 37.958 added;
- 3959: 8/12/15: 0%->100
- 3960: tested REL-13 WI: UTRA_LTE_iPos_enh-Core¦26/9/1¦20/12/16:21/3/17: Compl:
- 3961: no Perf. part¦follow-up WI of SI FS_UTRA_SDATA
- 3962: no Perf. part¦follow-up WI of SI FS_UTRA_SDATA 29/09/15: Compl:0%->25% 29/09/15: CD:Tue 15/03/16->Tue 15/12/15 29/09/15: WID: RP-151092->RP-151292 29/09/15: Stat Rep: -->RP-151291 29/09/15: Release: Rel-14->Rel-13
- 3963: ¦22/3/16: Compl:0%->100%
- 3964: REL-independent from REL-9
- 3965: REL-independent from REL-9. Aug 15: TR numb added 29/09/15: Compl:0%->15% 29/09/15: CD:Tue 15/03/16->Tue 15/12/15 29/09/15: Stat Rep: -->RP-151207 29/09/15: Release: Rel-14->Rel-13;
- 3966: REL-independent from REL-9 29/09/15: CD:Tue 15/03/16->Tue 15/12/15 29/09/15: Stat Rep: -->RP-151207 29/09/15: Release: Rel-14->Rel-13

| ID | WBS | Task | Duration | Start | Finish | Complete | Remaining | Baseline start | Baseline finish | Baseline duration | Total slack | Constraint | Resources | Work | Actual work | Acronym | PCG approved | WI rapporteur name | Release | TSG approved | Status Report | WI rapporteur e-mail | MCC resp | Special Focus Doc | Acronym_3GU_Export |
| --- | --- | --- | --- | --- | --- | --- | --- | --- | --- | --- | --- | --- | --- | --- | --- | --- | --- | --- | --- | --- | --- | --- | --- | --- | --- |
| 3967 | 1523 | **European 700 Supplemental Downlink band (738-758 MHz) in E-UTRA and LTE Carrier Aggregation (2DL/1UL) with Band 20** | 132d? | 2015-06-15 A | 2015-12-15 A | 100% |  |  |  |  |  |  | R4 | 3168h | 3168h | LTE_CA_700EU_B20 | 35 | TeliaSonera | Rel-13 | 68 |  |  |  |  |  |
| 3968 | 1523.1 | Core part: European 700 Supplemental Downlink band (738-758 MHz) in E-UTRA and LTE Carrier Aggregation (2DL/1UL) with Band 20 | 132d? | 2015-06-15 A | 2015-12-15 A | 100% |  |  |  |  |  | finish no earlier than 2015-12-15 | R4 | 1056h | 1056h | LTE_CA_700EU_B20-Core | 35 | TeliaSonera | Rel-13 | 68 | RP-151232 |  |  |  |  |
| 3969 | 1523.2 | Perf. part: European 700 Supplemental Downlink band (738-758 MHz) in E-UTRA and LTE Carrier Aggregation (2DL/1UL) with Band 20 | 132d? | 2015-06-15 A | 2015-12-15 A | 100% |  |  |  |  |  | finish no earlier than 2016-03-15 | R4 | 1056h | 1056h | LTE_CA_700EU_B20-Perf | 35 | TeliaSonera | Rel-13 | 68 | RP-151232 |  |  |  |  |
| 3970 | 1524 | Release 13 Features on Internet of Things (IoT) | 438.25d? | 2013-09-12 A | 2015-05-12 A | 100% |  | 2015-04-14 | 2015-12-25 | 183.25d? |  |  | SP; RP; CP; GP | 14024h | 14024h |  |  |  | Rel-13 |  |  |  |  |  |  |
| 3971 | 1525 | Service Requirements Maintenance for Machine-Type Communications (MTC) | 194d? | 2015-09-15 A | 2016-06-10 A | 100% |  | 2013-12-12 | 2014-12-10 | 261d? |  |  | S1 | 1552h | 1552h | SRMMTC | 32 | KPN | Rel-13 | 62 |  | toon.norp@tno.nl | Alain | MTC, M2M | SRMMTC |
| 3972 | 1526 | **Cellular (Narrowband) Internet of Things** | 590d? | 2015-09-15 A | 2017-12-15 A | 100% |  |  |  |  |  |  |  | 16648h | 16648h | CIoT | 36 |  | Rel-13 | 70 |  |  |  |  |  |
| 3973 | 1526.1 | Stage 2 of CIoT | 1d? | 2015-10-05 A | 2015-10-05 A | 100% |  |  |  |  |  | start no earlier than 2015-10-05 | S2 | 8h | 8h | CIoT | 36 | Intel, Puneet Jain | Rel-13 | 70 |  | puneet.jain@intel.com |  |  |  |
| 3974 | 1526.2 | Security Aspects of CIoT (aka NB-IoT) | 160d? | 2015-11-02 A | 2016-06-10 A | 100% |  |  |  |  |  | finish no earlier than 2016-06-10 | S3 | 1280h | 1280h | CIoT | 36 | Tim Evans, Vodafone | Rel-13 | 70 |  |  |  |  |  |
| 3975 | 1526.3 | **CT aspects of CIoT** | 138d? | 2015-12-07 A | 2016-06-15 A | 100% |  |  |  |  |  |  | C1 | 4976h | 4976h | CIoT-CT | 36 | Intel, Vivek Gupta | Rel-13 | 70 |  | vivek.g.gupta@intel.com |  |  |  |
| 3976 | 1526.3.1 | CT1 aspects of CIoT | 70d? | 2015-12-07 A | 2016-03-11 A | 100% |  |  |  |  |  | finish no earlier than 2016-03-11 | C1 | 560h | 560h | CIoT-CT | 36 | Intel, Vivek Gupta | Rel-13 | 70 |  | vivek.g.gupta@intel.com |  |  |  |
| 3977 | 1526.3.2 | CT3 aspects of CIoT | 138d? | 2015-12-07 A | 2016-06-15 A | 100% |  |  |  |  |  | finish no earlier than 2016-06-15 | C3 | 1104h | 1104h | CIoT-CT | 36 | Intel, Vivek Gupta | Rel-13 | 70 |  | vivek.g.gupta@intel.com |  |  |  |
| 3978 | 1526.3.3 | CT4 aspects of CIoT | 138d? | 2015-12-07 A | 2016-06-15 A | 100% |  |  |  |  |  | finish no earlier than 2016-06-15 | C4 | 1104h | 1104h | CIoT-CT | 36 | Intel, Vivek Gupta | Rel-13 | 70 |  | vivek.g.gupta@intel.com |  |  |  |
| 3979 | 1526.3.4 | CT6 aspects of CIoT | 138d? | 2015-12-07 A | 2016-06-15 A | 100% |  |  |  |  |  | finish no earlier than 2016-06-15 | C6 | 1104h | 1104h | CIoT-CT | 36 | Intel, Vivek Gupta | Rel-13 | 70 |  | vivek.g.gupta@intel.com |  |  |  |
| 3980 | 1526.4 | Charging Aspects of CIoT | 23d? | 2016-05-12 A | 2016-06-13 A | 100% |  |  |  |  |  | finish no earlier than 2016-06-13 | S5 | 184h | 184h | CIoT-CH | 37 | Gardella, Maryse (Nokia) | Rel-13 | 72 |  | Gardella, Maryse (Nokia) |  |  |  |
| 3981 | 1526.5 | **RAN aspects of CIoT aka Narrowband Internet of Things (IOT)** | 329d? | 2015-09-15 A | 2016-12-15 A | 100% |  |  |  |  |  |  | R1 | 6320h | 6320h | NB_IOT | 35 | Vodafone | Rel-13 | 69 |  |  |  |  |  |
| 3982 | 1526.5.1 | Core part: Narrowband Internet of Things (IOT) | 197d? | 2015-09-15 A | 2016-06-15 A | 100% |  |  |  |  |  | finish no earlier than 2016-06-15 | R1 | 1576h | 1576h | NB_IOT-Core | 35 | Vodafone | Rel-13 | 69 |  |  |  |  |  |
| 3983 | 1526.5.2 | Perf. part: Narrowband Internet of Things (IOT) | 264d? | 2015-12-15 A | 2016-12-15 A | 100% |  |  |  |  |  | finish no earlier than 2016-12-15 | R4 | 2112h | 2112h | NB_IOT-Perf | 36 | Vodafone | Rel-13 | 70 |  |  |  |  |  |
| 3984 | 1526.6 | Management for NB-IoT | 25d? | 2016-05-12 A | 2016-06-15 A | 100% |  |  |  |  |  | finish no earlier than 2016-06-15 | S5 | 200h | 200h | NB_IOT-OAM | 37 | Huawei, Kai ZHANG | Rel-13 | 72 |  | kai.zhangkai@huawei.com |  |  |  |
| 3985 | 1526.7 | UE Conformance Test Aspects - Narrowband Internet of Things (NB-IOT) | 460d? | 2016-03-15 A | 2017-12-15 A | 100% |  |  |  |  |  | finish no earlier than 2017-12-15 | R5 | 3680h | 3680h | NB_IOT-UEConTest | 36 | CMCC | Rel-13 | 71 |  |  |  |  |  |
| 3986 | 1527 | **Extended Coverage GSM (EC-GSM) for support of Cellular Internet of Things** | 255.5d? | 2015-09-25 A | 2016-09-15 | 69% | 77.98d? |  |  |  | 2472d |  | G1; G2 | 8864h | 4044.7h | CIoT_EC_GSM | 35 | Marteen Sunberg, Ericsson | Rel-13 | 69 |  | Marteen.Sunberg@Ericsson.com |  |  |  |
| 3987 | 1527.1 | Extended Coverage GSM (EC-GSM) for support of Cellular Internet of Things Core part | 164.5d? | 2015-09-25 A | 2016-05-12 A | 100% |  |  |  |  |  | finish no earlier than 2016-05-12 | G1; G2 | 2632h | 2632h | CIoT_EC_GSM-Core | 36 | Marteen Sunberg, Ericsson | Rel-13 | 70 |  | Marteen.Sunberg@Ericsson.com |  |  |  |
| 3988 | 1527.2 | Test for CIoT_EC_GSM | 132d? | 2015-11-11 | 2016-05-12 |  |  |  |  |  | 2563d | start no earlier than 2015-11-11 | G3 | 1056h |  | CIoT_EC_GSM_GERAN3new | 36 | Sierra Wireless S.A | Rel-13 | 70 |  | Marteen.Sunberg@Ericsson.com |  |  |  |
| 3989 | 1527.3 | Perf. Part: Extended Coverage GSM (EC-GSM) for support of Cellular Internet of Things | 68d? | 2016-06-15 A | 2016-09-15 A | 100% |  |  |  |  |  | finish no earlier than 2016-09-15 | R6 | 544h | 544h | CIoT_EC_GSM-Perf | 37 | Ericsson | Rel-13 | 72 |  |  |  |  |  |
| 3990 | 1527.4 | MS Conformance Test Aspects - Extended Coverage GSM (EC-GSM) for support of Cellular Internet of Things | 68d? | 2016-06-15 A | 2016-09-15 A | 100% |  |  |  |  |  | finish no earlier than 2016-09-15 | R5 | 544h | 544h | CIoT_EC_GSM-MSConTest | 37 | Ericsson | Rel-13 | 72 |  |  |  |  |  |

Notes:
- 3967: introduction of new DL only band and 2DL/1UL CA with it
- 3968: introduction of new DL only band and 2DL/1UL CA with it. Aug 15: TR numb added 29/09/15: Compl:0%->80% 29/09/15: CD:Tue 15/03/16->Tue 15/12/15 29/09/15: WID: RP-150861->RP-151228 29/09/15: Stat Rep: -->RP-151232 29/09/15: Release: Rel-14->Rel-13 / Impacted TSs and TRs: 36.895
- 3969: introduction of new DL only band and 2DL/1UL CA with it 29/09/15: WID: RP-150861->RP-151228 29/09/15: Stat Rep: -->RP-151232 29/09/15: Release: Rel-14->Rel-13
- 3970: -
- 3971: SP#65 completed. Linked to Rel-13 SEES, Rel-12 Support for Interworking with M2M Service Enablement (MTCe-SIMSE), Service Requirement Maintenance (MTCe-SRM). Decide which MTC reqs with no Stage 2 should be removed/maintained in Rel-13. / Impacted TSs and TRs: 22.368
- 3973: 7/3/16: 0%->95 / Impacted TSs and TRs: 23.401; 23.682; 23.251
- 3974: 7/3/16: 0%->39¦19/9/16: 39%->100 / Impacted TSs and TRs: 33.401
- 3975: 11/6/16: WID:CP-150795->CP-160292
- 3976: 7/3/16: 0%->35¦11/6/16: 35%->100¦11/6/16: WID:CP-150795->CP-160292 / Impacted TSs and TRs: 24.301; 24.008; 23.122
- 3977: 7/3/16: 0%->90¦11/6/16: WID:CP-150795->CP-160292¦13/6/16: 90%->100 / Impacted TSs and TRs: 29.061; 29.212
- 3978: 7/3/16: 0%->65¦11/6/16: WID:CP-150795->CP-160292¦13/6/16: 65%->100 / Impacted TSs and TRs: 29.272; 29.274; 23.008; 23.007; 29.128; 29.275; 29.230; 29.336; 29.281; 29.002; 29.303
- 3979: 11/6/16: WID:CP-150795->CP-160292¦13/6/16: 0%->100 / Impacted TSs and TRs: 31.102
- 3980: 32.25x¦13/6/16: 0%->100 / Impacted TSs and TRs: 32.25x; 32.240; 32.251; 32.274; 32.299; 32.298; 32.297
- 3981: no Perf. part¦note: WI only stays in REL-13 because of PCG decision
- 3982: no Perf. part¦note: WI only stays in REL-13 because of PCG decision1/1/16: Compl:0%->25% 22/3/16: Compl:25%->75%;1/7/16: Com / Impacted TSs and TRs: 36.802
- 3983: 22/3/16: WID: RP-152284->RP-160656¦1/7/16: WID: RP-160656->RP-16093326/9/16: Compl:0%->60%26/9/16: CD:Thu 15/09/16->Thu 15/12/16¦20/12/16: Compl:60%->100%¦20/12/16: WID: RP-160933->RP-162134
- 3984: 13/6/16: 0%->100 / Impacted TSs and TRs: 28.657; 28.658; 28.659; 32.425
- 3985: testing REL-13 NB_IOT-Core1/7/16: Compl:0%->5%¦26/9¦20/12/1¦21/3/17: Compl: ;
- 3986: 7/12/15: 0%->60
- 3987: 7/12/15:created by MCC to distinguish core versus test parts. 2/3/16: FCD: 11/15->05/16, 40->90%¦13/6/16: 90%->100
- 3988: 7/12/15: created GERAN. 2/3/16: G1,G2->G3, Acronym: CIoT_EC_GSM-Test->CIoT_EC_GSM_GERAN3new
- 3989: related to GERAN REL-13 WI CIoT_EC_GSM-Core26/9/16: Compl:0%->100%
- 3990: tested REL-13 WI: CIoT_EC_GSM-Core26/9/16: Compl

| ID | WBS | Task | Duration | Start | Finish | Complete | Remaining | Baseline start | Baseline finish | Baseline duration | Total slack | Constraint | Resources | Work | Actual work | Acronym | PCG approved | WI rapporteur name | WI rapporteur e-mail | Release | TSG approved | Status Report | Acronym_3GU_Export |
| --- | --- | --- | --- | --- | --- | --- | --- | --- | --- | --- | --- | --- | --- | --- | --- | --- | --- | --- | --- | --- | --- | --- | --- |
| 3991 | 1528 | **Extended DRX cycle for Power Consumption** | 468d? | 2014-12-03 A | 2016-09-15 | 93% | 31.26d? |  |  |  | 2472d |  | S2; R2; G2 | 27696h | 16791.6h | eDRX | 35 | Miguel Griot | mgriot@qti.qualcomm.com | Rel-13 | 68 |  |  |
| 3992 | 1528.1 | Study on Extended DRX cycle for Power Consumption Optimization | 268d? | 2014-12-03 A | 2015-12-11 A | 100% |  |  |  |  |  | finish no earlier than 2015-12-11 | S2 | 2144h | 2144h | FS_eDRX | 34 | Miguel Griot, Qualcomm | mgriot@qti.qualcomm.com | Rel-13 | 66 |  |  |
| 3993 | 1528.2 | Stage 2 for Extended DRX cycle for Power Consumption | 133d? | 2015-06-15 A | 2015-12-16 A | 100% |  |  |  |  |  | finish no earlier than 2015-12-16 | S2 | 1064h | 1064h | eDRX | 35 | Miguel Griot | mgriot@qti.qualcomm.com | Rel-13 | 68 |  |  |
| 3994 | 1528.3 | **CT aspects of extended DRX cycle** | 135d? | 2015-09-07 A | 2016-03-11 A | 100% |  |  |  |  |  |  | ct | 4912h | 4912h | eDRX-CT | 35 | Catovic, Amer, Qualcomm | Catovic, Amer, Qualcomm | Rel-13 | 69 |  |  |
| 3995 | 1528.3.1 | CT1 aspects of extended DRX cycle | 135d? | 2015-09-07 A | 2016-03-11 A | 100% |  |  |  |  |  | finish no earlier than 2016-03-11 | C1 | 1080h | 1080h | eDRX-CT | 35 | Catovic, Amer, Qualcomm | Catovic, Amer, Qualcomm | Rel-13 | 69 |  |  |
| 3996 | 1528.3.2 | CT3 aspects of extended DRX cycle | 135d? | 2015-09-07 A | 2016-03-11 A | 100% |  |  |  |  |  | finish no earlier than 2016-03-11 | C3 | 1080h | 1080h | eDRX-CT | 35 | Catovic, Amer, Qualcomm | Catovic, Amer, Qualcomm | Rel-13 | 69 |  |  |
| 3997 | 1528.3.3 | CT4 aspects of extended DRX cycle | 74d? | 2015-09-07 A | 2015-12-17 A | 100% |  |  |  |  |  | finish no earlier than 2015-12-17 | C4 | 592h | 592h | eDRX-CT | 35 | Catovic, Amer, Qualcomm | Catovic, Amer, Qualcomm | Rel-13 | 69 |  |  |
| 3998 | 1528.3.4 | CT6 aspects of extended DRX cycle | 135d? | 2015-09-07 A | 2016-03-11 A | 100% |  |  |  |  |  | finish no earlier than 2016-03-11 | C6 | 1080h | 1080h | eDRX-CT | 36 | Catovic, Amer, Qualcomm | Catovic, Amer, Qualcomm | Rel-13 | 70 |  |  |
| 3999 | 1528.4 | **RAN enhancements for extended DRX in LTE** | 262d? | 2015-03-16 A | 2016-03-15 A | 100% |  |  |  |  |  |  | R2 | 4192h | 4192h | LTE_extDRX | 34 | Qualcomm |  | Rel-13 | 67 |  |  |
| 4000 | 1528.4.1 | Core part: RAN enhancements for extended DRX in LTE | 262d? | 2015-03-16 A | 2016-03-15 A | 100% |  |  |  |  |  | finish no earlier than 2016-03-15 | R2 | 2096h | 2096h | LTE_extDRX-Core | 34 | Qualcomm |  | Rel-13 | 67 | RP-151338 |  |
| 4001 | 1528.5 | UE Conformance Test Aspects - RAN enhancements for extended DRX in LTE | 134d? | 2016-03-15 A | 2016-09-15 A | 100% |  |  |  |  |  | finish no earlier than 2016-12-15 | R5 | 1072h | 1072h | LTE_extDRX-UEConTest | 36 | Qualcomm |  | Rel-13 | 71 |  |  |
| 4002 | 1528.6 | **Extended DRX (eDRX) for GSM** | 184.5d? | 2015-08-28 A | 2016-05-12 | 44% | 102.46d? |  |  |  | 2563d |  | G2; G1 | 4832h | 2072.8h | eDRX_GSM | 35 | John Diachina, Ericsson LM | John.Diachina@Ericsson.com | Rel-13 | 69 |  |  |
| 4003 | 1528.6.1 | Core Part: Extended DRX (eDRX) for GSM | 60.5d? | 2015-08-28 A | 2015-11-20 A | 100% |  |  |  |  |  | finish no earlier than 2015-11-20 | G2; G1 | 968h | 968h | eDRX_GSM-Core | 36 | John Diachina, Ericsson LM | John.Diachina@Ericsson.com | Rel-13 | 70 |  |  |
| 4004 | 1528.6.2 | MS test: Extended DRX (eDRX) for GSM | 114d? | 2015-12-07 A | 2016-05-12 | 15% | 96.9d? |  |  |  | 2563d | start no earlier than 2015-12-07 | G3 | 912h | 136.8h | eDRX_GSM_GERAN3new | 36 | Sierra Wireless S.A | John.Diachina@Ericsson.com | Rel-13 | 70 |  |  |
| 4005 | 1529 | **Optimizations to Support High Latency Communications** | 326d? | 2014-09-19 A | 2015-12-16 A | 100% |  |  |  |  |  |  | S2 | 5824h | 5824h | HLcom | 34 | Ericsson, Hans Rönneke | hans.ronneke(at)ericsson.com | Rel-13 | 67 |  |  |
| 4006 | 1529.1 | Study on Optimizations to support High Latency communications | 196d? | 2014-09-19 A | 2015-06-17 A | 100% |  |  |  |  |  | finish no earlier than 2015-06-17 | S2 | 1568h | 1568h | FS_HLcom | 33 | Ericsson | hans.ronneke@ericsson.com | Rel-13 | 65 |  | FS_HLcom |
| 4007 | 1529.2 | Optimizations to Support High Latency Communications | 73d? | 2015-03-05 A | 2015-06-15 A | 100% |  |  |  |  |  | finish no earlier than 2015-06-15 | S2 | 584h | 584h | HLcom | 34 | Ericsson, Hans Rönneke | hans.ronneke(at)ericsson.com | Rel-13 | 67 |  |  |
| 4008 | 1529.3 | CT aspects of Optimizations to Support High Latency | 133d? | 2015-06-15 A | 2015-12-16 A | 100% |  |  |  |  |  | finish no earlier than 2015-12-16 | C4 | 1064h | 1064h | HLcom-CT | 35 | Yong Yang, Ericsson | frank.yong.yang@ericsson.com | Rel-13 | 68 |  |  |
| 4009 | 1530 | **Further LTE Physical Layer Enhancements for MTC** | 789d? | 2014-09-12 A | 2017-09-15 A | 100% |  | 2014-06-13 | 2015-06-12 | 261d? |  |  | R1; R4; R2 | 36320h | 36320h | LTE_MTCe2_L1 | 33 | Ericsson | johan.bergman@ericsson.com | Rel-13 | 65 |  | LTE_MTCe2_L1 |
| 4010 | 1530.1 | Core part: Further LTE Physical Layer Enhancements for MTC | 395d? | 2014-09-12 A | 2016-03-15 A | 100% |  | 2014-06-13 | 2015-06-12 | 261d? |  | finish no earlier than 2016-03-15 | R1; R2; R4 | 9480h | 9480h | LTE_MTCe2_L1-Core | 33 | Ericsson | johan.bergman@ericsson.com | Rel-13 | 65 | RP-151186 | LTE_MTCe2_L1-Core |
| 4011 | 1530.2 | Perf. Part: Further LTE Physical Layer Enhancements for MTC | 593d? | 2014-09-12 A | 2016-12-15 A | 100% |  | 2014-06-13 | 2015-06-12 | 261d? |  | finish no earlier than 2016-12-15 | R4 | 4744h | 4744h | LTE_MTCe2_L1-Perf | 33 | Ericsson | johan.bergman@ericsson.com | Rel-13 | 65 |  | LTE_MTCe2_L1-Perf |
| 4012 | 1530.3 | UE Conformance Test Aspects - Further LTE Physical Layer Enhancements for MTC | 395d? | 2016-03-15 A | 2017-09-15 A | 100% |  |  |  |  |  | finish no earlier than 2017-09-15 | R5 | 3160h | 3160h | LTE_MTCe2_L1-UEConTest | 36 | Ericsson |  | Rel-13 | 71 |  |  |
| 4013 | 1531 | EGPRS Access Security Enhancements in relation to Cellular IoT | 128d? | 2015-09-16 A | 2016-03-11 A | 100% |  |  |  |  |  | finish no earlier than 2016-03-11 | S3 | 1024h | 1024h | EASE_EC_GSM | 35 | Vesa Torvinen, Ericsson |  | Rel-13 | 69 |  |  |
| 4014 | 1532 | **Group based Enhancements** | 394d? | 2014-06-18 A | 2015-12-16 A | 100% |  | 2014-06-18 | 2015-09-16 | 326d? |  |  | S2; S3 | 18676.8h | 18676.8h | GROUPE | 33 | Huawei | ZhangWanqiang@huawei.com | Rel-13 | 64 |  | GROUPE |
| 4015 | 1532.1 | TR for Group based Enhancements | 196d? | 2014-06-18 A | 2015-03-18 A | 100% |  | 2014-06-18 | 2015-03-18 | 196d? |  | finish no earlier than 2015-03-18 | S2 | 1568h | 1568h | GROUPE | 33 | Huawei, Wanqiang Zhang | ZhangWanqiang@huawei.com | Rel-13 | 64 |  |  |
| 4016 | 1532.2 | Stage 2 for Group based Enhancements | 261d? | 2014-06-23 A | 2015-06-17 A | 100% |  | 2014-06-18 | 2015-06-17 | 261d? |  | finish no earlier than 2015-06-17 | S2 | 2088h | 2088h | GROUPE | 33 | Huawei | ZhangWanqiang@huawei.com | Rel-13 | 64 |  |  |
| 4017 | 1532.3 | TR on Security for Group based Enhancements | 231.6d? | 2014-06-18 A | 2015-06-12 A | 100% |  | 2014-06-18 | 2015-06-17 | 231.6d? |  | start no earlier than 2014-06-18 | S3 | 1852.8h | 1852.8h | GROUPE | 33 | Samsung | Rajavelsamy R (rajvel@samsung.com) | Rel-13 | 64 |  |  |
| 4018 | 1532.4 | Security for Group based Enhancements | 326d? | 2014-06-23 A | 2015-09-16 A | 100% |  | 2014-06-18 | 2015-09-16 | 326d? |  | finish no earlier than 2015-09-16 | S3 | 2608h | 2608h | GROUPE | 33 | Samsung | Rajavelsamy R (rajvel@samsung.com) | Rel-13 | 64 |  |  |

Notes:
- 3991: June2015: WID:SP-150254->SP-150369 / Impacted TSs and TRs: 23.401; 23.060; 23.682; 23.271; 23.272
- 3992: No Ran aspects yet. GERAN in FS_uPoD.29/1: TS number added Mar15: 0->30%¦June2015: Compl:30%->95, Exc S granted in SP-150352¦07/09/15: 95%->100 / Impacted TSs and TRs: 23.770
- 3993: June2015: WID:SP-150254->SP-150369¦07/09/15: 0%->95¦7/12/15: 95%->99 / Impacted TSs and TRs: 23.401; 23.060; 23.682; 23.271; 23.272
- 3994: 14/09/15: WID:CP-150499->CP-150541
- 3995: 14/09/15: WID:CP-150499->CP-150541¦7/12/15: 25%->80. FCD ->03/16. ES in CP-150723¦7/3/16: 80%->100 / Impacted TSs and TRs: 24.301; 24.008; 29.118
- 3996: 14/09/15: WID:CP-150499->CP-150541. FCD ->03/16. ES in CP-150723¦8/12/15: 0%->100 / Impacted TSs and TRs: 29.338; 23.007; 29.274; 29.060; 29.172
- 3997: 14/09/15: WID:CP-150499->CP-150541¦7/12/15: 40%->100¦8/12/15: 100%->95¦8/3/16: 95%->100 / Impacted TSs and TRs: 29.212
- 3998: 7/12/15: Added. FCD ->03/16. ES in CP-150723¦8/3/16: 0%->100
- 4000: 03/07/15: Compl:0%->15% 03/07/15: Stat Rep: ->RP-150798 29/09/15: Compl:15%->35% 29/09/15: WID: RP-150493->RP-151339 29/09/15: Stat Rep: RP-150798->RP-151338 ¦22/3/16: Compl:95%->100%
- 4001: testing REL-13 LTE_extDRX-Core and CT1 feature eDRX-CT;
- 4002: 07/09/15: 0%->40¦7/12/15: 40%->100 / Impacted TSs and TRs: 43.064; 44.018; 44.060; 45.008; 48.018; 43.022
- 4003: 7/12/15: created by MCC to distinguish Core versus test parts / Impacted TSs and TRs: 43.064; 44.018; 44.060; 45.008; 48.018; 43.022
- 4004: 7/12/15: created by GERAN. 2/3/16: G1,G2->G3. Acronym: eDRX_GSM-Test -> eDRX_GSM_GERAN3new (to conform to WID)¦0->15%
- 4005: Impacted TSs and TRs: 23.401; 23.060; 23.682
- 4006: Dec.14: 0->30%. Mar15: 70%¦June2015: Compl:70%->100 / Impacted TSs and TRs: New 23.709
- 4007: June 2015: created by MCC as a result of the split of the one-line Feature into a several-lines Feature (now Stage 2 and Stage 3 aspects)¦June2015: Compl:0%->100. WID: SP-150030->SP-150252 / Impacted TSs and TRs: 23.401; 23.060; 23.682
- 4008: 07/09/15: 0%->80¦7/12/15: 80%->100 / Impacted TSs and TRs: 29.274; 29.060; 29.281; 23.008; 29.272; 29.230; 29.002; 29.336; 29.xyz
- 4009: Triggered by Rel-12 TR 36.888 Study on Provision of low-cost MTC UEs based on LTE (FS_LC_MTC_LTE) and Low cost & enhanced coverage MTC UE for LTE (LC_MTC_UE) / Impacted TSs and TRs: LTE
- 4010: 3/3/15: WID: RP-141865¦Stat Rep: -->RP-141785 1st Apr 15: Compl:10%->25% 1st Apr 15: WID: RP-141865->RP-150492 1st Apr 15: Stat Rep: RP-141785->RP-150495 03/07/15: Compl:25%->45% 03/07/15: Stat Rep: RP-150495->RP-150583 29/09/15: Compl:45%->65% 29/09 / Impacted TSs and TRs: 36.101; 36.104; 36.133; 36.201; 36.211; 36.212; 36.213; 36.214; 36.300; 36.302; 36.306; 36.321; 36.331
- 4011: ¦WID: RP-142043->RP-141865¦Stat Rep: -->RP-141785 1st Apr 15: WID: RP-141865->RP-150492 1st Apr 15: Stat Rep: RP-141785->RP-150495 03/07/15: Stat Rep: RP-150495->RP-150583 29/09/15: Stat Rep: RP-150583->RP-151186 ;26/9/16: Compl:70%-¦ / Impacted TSs and TRs: 36.101; 36.104; 36.133
- 4012: testing REL-13 LTE_MTCe2_L1-Core¦1/7/16: Compl:0%->6%¦26/¦2¦21/3/17: Compl:70% ;
- 4013: 7/12/15: 0%->5¦28/1/16: 33.420 added¦7/3/16: 5%->80¦11/6/16: 80%->98¦19/9/16: 98%->99¦21/3/17: 99%->100->99%¦7/6/17: 99%->100 / Impacted TSs and TRs: New 33.420
- 4014: - / Impacted TSs and TRs: Stage 2
- 4015: Dec.14: 20->70%. Mar15: 90%¦June2015: Compl:90%->100 / Impacted TSs and TRs: New 23.769
- 4016: Mar15: 0->20%¦June2015: Compl:20%->100 / Impacted TSs and TRs: 23.682; TBD
- 4017: TR 33.8xy will capture requirements, solution alternatives, evaluations and conclusions for the AESE, MONTE and GROUPE WIDs. 3/3/15: 5->10%.¦June2015: Compl:10%->60¦11/12/15: 60%->100 / Impacted TSs and TRs: New 33.889
- 4018: -¦11/12/15: 0%->100 / Impacted TSs and TRs: 33.187

| ID | WBS | Task | Duration | Start | Finish | Complete | Baseline start | Baseline finish | Baseline duration | Constraint | Resources | Work | Actual work | Acronym | PCG approved | WI rapporteur name | WI rapporteur e-mail | Release | TSG approved | Acronym_3GU_Export | Status Report | MCC resp | Special Focus Doc |
| --- | --- | --- | --- | --- | --- | --- | --- | --- | --- | --- | --- | --- | --- | --- | --- | --- | --- | --- | --- | --- | --- | --- | --- |
| 4019 | 1532.5 | **CT aspects of Group based Enhancements** | 133d? | 2015-06-15 A | 2015-12-16 A | 100% |  |  |  |  | C4 | 4256h | 4256h | GROUPE-CT | 35 | Peter Schmitt, Huawei | Peter.Schmitt@huawei.com | Rel-13 | 68 |  |  |  |  |
| 4020 | 1532.5.1 | CT1 aspects of Group based Enhancements | 133d? | 2015-06-15 A | 2015-12-16 A | 100% |  |  |  | start no earlier than 2015-06-15 | C1 | 1064h | 1064h | GROUPE-CT | 35 | Peter Schmitt, Huawei | Peter.Schmitt@huawei.com | Rel-13 | 68 |  |  |  |  |
| 4021 | 1532.5.2 | DELETED: CT3 aspects of Group based Enhancements | 133d? | 2015-06-15 A | 2015-12-16 A | 100% |  |  |  | start no earlier than 2015-06-15 | C3 | 1064h | 1064h | GROUPE-CT | 35 | Peter Schmitt, Huawei | Peter.Schmitt@huawei.com | Rel-13 | 68 |  |  |  |  |
| 4022 | 1532.5.3 | CT4 aspects of Group based Enhancements | 133d? | 2015-06-15 A | 2015-12-16 A | 100% |  |  |  | start no earlier than 2015-06-15 | C4 | 1064h | 1064h | GROUPE-CT | 35 | Peter Schmitt, Huawei | Peter.Schmitt@huawei.com | Rel-13 | 68 |  |  |  |  |
| 4023 | 1533 | **Monitoring Enhancements** | 456d? | 2014-06-18 A | 2016-03-11 A | 100% | 2014-06-18 | 2015-09-16 | 326d? |  | S2; S3 | 21684.8h | 21684.8h | MONTE | 33 | Intel | puneet.jain@intel.com | Rel-13 | 64 | MONTE |  |  |  |
| 4024 | 1533.1 | TR for Monitoring Enhancements | 196d? | 2014-09-17 A | 2015-06-17 A | 100% | 2014-09-17 | 2015-06-17 | 196d? | finish no earlier than 2015-06-17 | S2 | 1568h | 1568h | MONTE | 33 | Intel, Puneet Jain | puneet.jain@intel.com | Rel-13 | 64 |  |  |  |  |
| 4025 | 1533.2 | Stage 2 for Monitoring Enhancements | 261d? | 2014-06-23 A | 2015-06-17 A | 100% | 2014-06-18 | 2015-06-17 | 261d? | finish no earlier than 2015-06-17 | S2 | 2088h | 2088h | MONTE | 33 | Intel, Puneet Jain | puneet.jain@intel.com | Rel-13 | 64 |  |  |  |  |
| 4026 | 1533.3 | TR on Security for Monitoring Enhancements | 231.6d? | 2014-06-18 A | 2015-06-12 A | 100% | 2014-06-18 | 2015-06-17 | 231.6d? | start no earlier than 2014-06-18 | S3 | 1852.8h | 1852.8h | MONTE | 33 | Samsung | Rajavelsamy R (rajvel@samsung.com) | Rel-13 | 64 |  |  |  |  |
| 4027 | 1533.4 | Security for Monitoring Enhancements | 326d? | 2014-06-23 A | 2015-09-16 A | 100% | 2014-06-18 | 2015-09-16 | 326d? | finish no earlier than 2015-09-16 | S3 | 2608h | 2608h | MONTE | 33 | Samsung | Rajavelsamy R (rajvel@samsung.com) | Rel-13 | 64 |  |  |  |  |
| 4028 | 1533.5 | Charging aspects of MONTE | 128d? | 2015-09-16 A | 2016-03-11 A | 100% | 2014-06-18 | 2015-09-16 | 326d? | finish no earlier than 2016-03-11 | S5 | 1024h | 1024h | MONTE-CH | 35 | Huawei(Li Li, jasmine.li@huawei.com) | jasmine.li@huawei.com | Rel-13 | 69 |  |  |  |  |
| 4029 | 1533.6 | **Monitoring Enhancements CT aspects** | 195d? | 2015-06-15 A | 2016-03-11 A | 100% |  |  |  |  | C4 | 5248h | 5248h | MONTE-CT | 35 | Peter Schmitt, Huawei | peter.schmitt@huawei.com | Rel-13 | 68 |  |  |  |  |
| 4030 | 1533.6.1 | CT1 aspects of Monitoring Enhancements | 133d? | 2015-06-15 A | 2015-12-16 A | 100% |  |  |  | start no earlier than 2015-06-15 | C1 | 1064h | 1064h | MONTE-CT | 35 | Peter Schmitt, Huawei | peter.schmitt@huawei.com | Rel-13 | 68 |  |  |  |  |
| 4031 | 1533.6.2 | CT3 aspects of Monitoring Enhancements | 133d? | 2015-06-15 A | 2015-12-16 A | 100% |  |  |  | start no earlier than 2015-06-15 | C3 | 1064h | 1064h | MONTE-CT | 35 | Peter Schmitt, Huawei | peter.schmitt@huawei.com | Rel-13 | 68 |  |  |  |  |
| 4032 | 1533.6.3 | CT4 aspects of Monitoring Enhancements | 195d? | 2015-06-15 A | 2016-03-11 A | 100% |  |  |  | finish no earlier than 2016-03-11 | C4 | 1560h | 1560h | MONTE-CT | 35 | Peter Schmitt, Huawei | peter.schmitt@huawei.com | Rel-13 | 68 |  |  |  |  |
| 4033 | 1534 | **Dedicated Core Networks** | 456d? | 2014-06-18 A | 2016-03-11 A | 100% | 2014-06-18 | 2015-03-18 | 196d? |  | S2 | 11518.4h | 11518.4h | DECOR | 33 | NTT DOCOMO | Daisuke Fujishima (fujishimad@nttdocomo.co.jp) | Rel-13 | 64 | DECOR |  |  |  |
| 4034 | 1534.1 | TR for Dedicated Core Networks | 128d? | 2014-06-18 A | 2014-12-12 A | 100% | 2014-06-18 | 2014-12-10 | 126d? | finish no earlier than 2014-12-12 | S2 | 1024h | 1024h | DECOR | 33 | NTT DOCOMO | Daisuke Fujishima (fujishimad@nttdocomo.co.jp) | Rel-13 | 64 |  |  |  |  |
| 4035 | 1534.2 | Stage 2 for Dedicated Core Networks | 196d? | 2014-06-23 A | 2015-03-18 A | 100% | 2014-06-18 | 2015-03-18 | 196d? | finish no earlier than 2015-03-18 | S2 | 1568h | 1568h | DECOR | 33 | NTT DOCOMO | Daisuke Fujishima (fujishimad@nttdocomo.co.jp) | Rel-13 | 64 |  |  |  |  |
| 4036 | 1534.3 | **CT aspects of Dedicated Core Networks** | 186.8d? | 2015-06-25 A | 2016-03-11 A | 100% |  |  |  |  | ct | 3166.4h | 3166.4h | DECOR-CT | 35 | Huawei, Xiaoyan SHI (Sean.shixiaoyan@huawei.com) | Huawei, Xiaoyan SHI (Sean.shixiaoyan@huawei.com) | Rel-13 | 69 |  |  |  |  |
| 4037 | 1534.3.1 | CT1 aspects for Dedicated Core Networks CT aspects | 74d? | 2015-09-07 A | 2015-12-17 A | 100% |  |  |  | finish no earlier than 2015-12-17 | C1 | 592h | 592h | DECOR-CT | 35 | Huawei |  | Rel-13 | 69 |  |  |  |  |
| 4038 | 1534.3.2 | CT4 aspects for Dedicated Core Networks CT aspects | 135d? | 2015-06-25 A | 2016-03-11 A | 100% |  |  |  | finish no earlier than 2016-03-11 | C4 | 1080h | 1080h | DECOR-CT | 35 |  |  | Rel-13 | 69 |  |  |  |  |
| 4039 | 1534.4 | **Dedicated Core Networks RAN Aspects** | 132d? | 2015-06-15 A | 2015-12-15 A | 100% |  |  |  |  | R3 | 2112h | 2112h | DECOR-UTRA_LTE | 35 | Ericsson |  | Rel-13 | 68 |  |  |  |  |
| 4040 | 1534.4.1 | Core part: Dedicated Core Networks | 132d? | 2015-06-15 A | 2015-12-15 A | 100% |  |  |  | finish no earlier than 2015-12-15 | R3 | 1056h | 1056h | DECOR-UTRA_LTE-Core | 35 | Ericsson |  | Rel-13 | 68 |  | RP-151290 |  |  |
| 4041 | 1535 | **Service Exposure and Enablement Support** | 268d? | 2013-09-12 A | 2014-09-17 A | 100% | 2013-09-12 | 2014-09-17 | 267d? |  | S1 | 5880h | 5880h | SEES | 31 | KPN | toon.norp@tno.nl | Rel-13 | 61 | SEES | S1-143301 | Alain | MTC, M2M |
| 4042 | 1535.1 | TR on Stage 1 for Service Exposure and Enablement Support | 202d? | 2013-09-12 A | 2014-06-18 A | 100% | 2013-09-12 | 2014-06-18 | 202d? | finish no earlier than 2014-06-18 | S1 | 1608h | 1608h | SEES | 31 | KPN | toon.norp@tno.nl | Rel-13 | 61 |  | S1-143301 | Alain | MTC, M2M |
| 4043 | 1535.2 | Stage 1 for Service Exposure and Enablement Support | 266d? | 2013-09-12 A | 2014-09-17 A | 100% | 2013-09-12 | 2014-09-17 | 266d? | finish no earlier than 2014-09-17 | S1 | 2128h | 2128h | SEES | 31 | KPN | toon.norp@tno.nl | Rel-13 | 61 |  | S1-143301 | Alain | MTC, M2M |

Notes:
- 4019: 7/12/15: WID:CP-150240->CP-150816 / Impacted TSs and TRs: 24.008; 24.301; 29.468; 29.272; 23.008; 29.336; 29.303; 29.002; 29.230; 29.305; 23.003
- 4020: 07/09/15: 0%->15¦7/12/15: 15%->100¦7/12/15: WID:CP-150240->CP-150816 / Impacted TSs and TRs: 24.008; 24.301
- 4021: 7/12/15: WID:CP-150240->CP-150816. CT3 task removed / Impacted TSs and TRs: 29.468
- 4022: 07/09/15: 0%->80¦7/12/15: 80%->100¦7/12/15: WID:CP-150240->CP-150816 / Impacted TSs and TRs: 29.272; 23.008; 29.336; 29.303; 29.002; 29.230; 29.305; 23.003
- 4023: Linked to Rel-13 Feature Architecture Enhancements for Service Exposure (AESE). Although service requirements (TS 22.368 clause 7.2.8) are motivated by MTC, the solution may apply to normal UEs¦5/10/15: 32.278 added; / Impacted TSs and TRs: 32.278
- 4024: Dec.14: 25->85%. Mar15: 100% / Impacted TSs and TRs: New 23.789
- 4025: -¦June2015: Compl:0%->100 / Impacted TSs and TRs: 23.682; TBD
- 4026: TR 33.8xy will capture requirements, solution alternatives, evaluations and conclusions for the AESE, MONTE and GROUPE WIDs.3/3/15: 5->10%.¦June2015: Compl:10%->15¦11/12/15: 15%->100 / Impacted TSs and TRs: New 33.889
- 4027: -¦11/12/15: 0%->100 / Impacted TSs and TRs: 33.187
- 4028: 7/10/15: acronym changed from "MONTE" to "MONTE-CH"¦7/12/15: 0%->50. ES in SP-150709 (wrong UID in the ES)¦7/3/16: 25%->100 / Impacted TSs and TRs: 32.27x; 32.240; 32.299; 32.298
- 4029: 14/09/15: WID:CP-150396->CP-150422
- 4030: 07/09/15: 0%->95¦14/09/15: WID:CP-150396->CP-150422¦7/12/15: 95%->100 / Impacted TSs and TRs: 24.301; 24.008
- 4031: 07/09/15: 0%->100¦14/09/15: WID:CP-150396->CP-150422 / Impacted TSs and TRs: 29.214; 29.213; 29.201
- 4032: 61907/09/15: 0%->50¦14/09/15: WID:CP-150396->CP-150422¦7/12/15: 50%->85. FCD -> 03/16, ES in CP-150619¦7/3/16: 85%->100 / Impacted TSs and TRs: New 29.128; 29.272; 29.002; 29.336; 29.230; 23.008
- 4033: 06/15: WID: SP-140707-> SP-150249 / Impacted TSs and TRs: Stage 2
- 4034: Dec.14: 30->100%. 06/15: WID: SP-140707-> SP-150249 / Impacted TSs and TRs: New 23.707
- 4035: Mar15: 0->70%¦June2015: Compl:70%->100, WID: SP-140707-> SP-150249 / Impacted TSs and TRs: 23.060; 23.401; 23.236
- 4037: 7/12/15: 0%->100 / Impacted TSs and TRs: 24.301; 24.008
- 4038: 7/12/15: 70%->90. FCD -> 03/16, ES CP-150617¦7/3/16: 90%->100 / Impacted TSs and TRs: 29.274; 29.060; 23.003; 29.272; 29.002; 29.305; 23.008; 29.230; 29.303; 23.007
- 4039: no Perf. part¦note: DECOR is a REL-13 SA2 WI;
- 4040: no Perf. part¦note: DECOR is a REL-13 SA2 WI¦29/09/15: Compl:0%->30% 29/09/15: Stat Rep: -->RP-1512901/1/16: Compl:30%->100%
- 4041: SP#62 completion 06/14=>09/14. Linked to Rel-12 Study TR 22.888 (FS_MTCe) and to Features Rel-11 SIMTC & Rel-12 MTCe and MOSAP / Impacted TSs and TRs: Stage 1
- 4042: SP#64 completed. TR 22.853v200 for Approval. External requirements from oneM2M TR0001(oneM2M Use Case collection), TS0002 (M2M Requirements) / Impacted TSs and TRs: New 22.853
- 4043: SP#65 completed / Impacted TSs and TRs: 22.101; 22.115; 22.368; TBD

| ID | WBS | Task | Duration | Start | Finish | Complete | Remaining | Baseline start | Baseline finish | Baseline duration | Total slack | Constraint | Resources | Work | Actual work | Acronym | PCG approved | WI rapporteur name | WI rapporteur e-mail | Release | TSG approved | Acronym_3GU_Export | MCC resp | Special Focus Doc | Status Report |
| --- | --- | --- | --- | --- | --- | --- | --- | --- | --- | --- | --- | --- | --- | --- | --- | --- | --- | --- | --- | --- | --- | --- | --- | --- | --- |
| 4044 | 1536 | **Architecture Enhancements for Service capability Exposure** | 456d? | 2014-06-18 A | 2016-03-11 A | 100% |  | 2014-06-18 | 2015-09-16 | 326d? |  |  | S2; S3 | 16027.2h | 16027.2h | AESE | 33 | Intel | puneet.jain@intel.com | Rel-13 | 64 | AESE |  |  |  |
| 4045 | 1536.1 | TR for Architecture Enhancements for Service capability Exposure | 196d? | 2014-06-18 A | 2015-03-18 A | 100% |  | 2014-06-18 | 2015-03-18 | 196d? |  | finish no earlier than 2015-03-18 | S2 | 1568h | 1568h | AESE | 33 | Intel, Puneet Jain | puneet.jain@intel.com | Rel-13 | 64 |  |  |  |  |
| 4046 | 1536.2 | Stage 2 for Architecture Enhancements for Service capability Exposure | 261d? | 2014-06-23 A | 2015-06-17 A | 100% |  | 2014-06-18 | 2015-06-17 | 261d? |  | finish no earlier than 2015-06-17 | S2 | 2088h | 2088h | AESE | 33 | Intel, Puneet Jain | puneet.jain@intel.com | Rel-13 | 64 |  |  |  |  |
| 4047 | 1536.3 | TR on Security for Architecture Enhancements for Service capability Exposure | 241.4d? | 2014-06-23 A | 2015-06-17 A | 100% |  | 2014-06-18 | 2015-06-17 | 241.4d? |  | finish no earlier than 2015-06-17 | S3 | 1931.2h | 1931.2h | AESE | 33 | Samsung | Rajavelsamy R (rajvel@samsung.com) | Rel-13 | 64 |  |  |  |  |
| 4048 | 1536.4 | Security for Architecture Enhancements for Service capability Exposure | 326d? | 2014-06-23 A | 2015-09-16 A | 100% |  | 2014-06-18 | 2015-09-16 | 326d? |  | finish no earlier than 2015-09-16 | S3 | 2608h | 2608h | AESE | 33 | Samsung | Rajavelsamy R (rajvel@samsung.com) | Rel-13 | 64 |  |  |  |  |
| 4049 | 1536.5 | **CT aspects of Architecture Enhancements for Service capability Exposure** | 195d? | 2015-06-15 A | 2016-03-11 A | 100% |  |  |  |  |  |  | C3 | 4184h | 4184h | AESE-CT | 35 | Yizhuang Wu, Huawei | wuyizhuang@huawei.com | Rel-13 | 68 |  |  |  |  |
| 4050 | 1536.5.1 | CT3 aspects of Architecture Enhancements for Service capability Exposure | 195d? | 2015-06-15 A | 2016-03-11 A | 100% |  |  |  |  |  | finish no earlier than 2016-03-11 | C3 | 1560h | 1560h | AESE-CT | 35 | Yizhuang Wu, Huawei. FCD+3, ES in 642 | wuyizhuang@huawei.com | Rel-13 | 68 |  |  |  |  |
| 4051 | 1536.5.2 | CT4 aspects of Architecture Enhancements for Service capability Exposure | 133d? | 2015-06-15 A | 2015-12-16 A | 100% |  |  |  |  |  | start no earlier than 2015-06-15 | C4 | 1064h | 1064h | AESE-CT | 35 | Yizhuang Wu, Huawei | wuyizhuang@huawei.com | Rel-13 | 68 |  |  |  |  |
| 4052 | 1537 | **Rel-13 LTE Carrier Aggregation** | 1315d? | 2013-12-09 A | 2018-12-14 | 95% | 67.21d? | 2014-03-06 | 2015-06-12 | 332d? | 1886d |  | R4 | 556616h | 514647h | LTE_CA_Rel13 | 32 |  |  | Rel-13 | 62 | LTE_CA_Rel-13 | Issam | CA |  |
| 4053 | 1537.1 | **LTE Advanced 4 Band Carrier Aggregation (4DL/1UL) of Band 4, Band 4, Band 5 and Band 12** | 66d? | 2015-09-15 A | 2015-12-15 A | 100% |  |  |  |  |  |  | R4 | 1584h | 1584h | LTE_CA_B4_B4_B5_B12 | 35 | US Cellular |  | Rel-13 | 69 |  |  |  |  |
| 4054 | 1537.1.1 | Core part:LTE Advanced 4 Band Carrier Aggregation (4DL/1UL) of Band 4, Band 4, Band 5 and Band 12 | 66d? | 2015-09-15 A | 2015-12-15 A | 100% |  |  |  |  |  | finish no earlier than 2016-03-15 | R4 | 528h | 528h | LTE_CA_B4_B4_B5_B12-Core | 35 | US Cellular |  | Rel-13 | 69 |  |  |  |  |
| 4055 | 1537.1.2 | Perf. part:LTE Advanced 4 Band Carrier Aggregation (4DL/1UL) of Band 4, Band 4, Band 5 and Band 12 | 66d? | 2015-09-15 A | 2015-12-15 A | 100% |  |  |  |  |  | finish no earlier than 2016-03-15 | R4 | 528h | 528h | LTE_CA_B4_B4_B5_B12-Perf | 35 | US Cellular |  | Rel-13 | 69 |  |  |  |  |
| 4056 | 1537.2 | **LTE Advanced 4 Band Carrier Aggregation (4DL/1UL) of Band 2, Band 4, Band 4 and Band 5** | 66d? | 2015-09-15 A | 2015-12-15 A | 100% |  |  |  |  |  |  | R4 | 1584h | 1584h | LTE_CA_B2_B4_B4_B5 | 35 | US Cellular |  | Rel-13 | 69 |  |  |  |  |
| 4057 | 1537.2.1 | Core part:LTE Advanced 4 Band Carrier Aggregation (4DL/1UL) of Band 2, Band 4, Band 4 and Band 5 | 66d? | 2015-09-15 A | 2015-12-15 A | 100% |  |  |  |  |  | finish no earlier than 2016-03-15 | R4 | 528h | 528h | LTE_CA_B2_B4_B4_B5-Core | 35 | US Cellular |  | Rel-13 | 69 |  |  |  |  |
| 4058 | 1537.2.2 | Perf. part:LTE Advanced 4 Band Carrier Aggregation (4DL/1UL) of Band 2, Band 4, Band 4 and Band 5 | 66d? | 2015-09-15 A | 2015-12-15 A | 100% |  |  |  |  |  | finish no earlier than 2016-03-15 | R4 | 528h | 528h | LTE_CA_B2_B4_B4_B5-Perf | 35 | US Cellular |  | Rel-13 | 69 |  |  |  |  |
| 4059 | 1537.3 | **LTE Advanced inter-band Carrier Aggregation of Band 8 and Band 27** | 531d? | 2013-12-09 A | 2015-12-15 | 30% | 371.7d? | 2013-12-09 | 2014-12-11 | 265d? | 2670d |  | R4 | 12696h | 2643.08h | LTE_CA_B8_B27 | 32 | KT | ilwhan.kim@kt.com | Rel-13 | 62 | LTE_CA_B8_B27 | Issam | CA |  |
| 4060 | 1537.3.1 | Core part:LTE Advanced inter-band Carrier Aggregation of Band 8 and Band 27 | 528d? | 2013-12-09 A | 2015-12-15 | 30% | 369.6d? | 2013-12-09 | 2014-12-11 | 265d? | 2670d | finish no earlier than 2015-12-15 | R4 | 4224h | 1267.2h | LTE_CA_B8_B27-Core | 32 | KT | ilwhan.kim@kt.com | Rel-13 | 62 | LTE_CA_B8_B27-Core | Issam | CA | RP-151131 |
| 4061 | 1537.3.2 | Perf. part:LTE Advanced inter-band Carrier Aggregation of Band 8 and Band 27 | 528d? | 2013-12-09 A | 2015-12-15 | 30% | 369.6d? | 2013-12-09 | 2014-12-11 | 265d? | 2670d | finish no earlier than 2015-12-15 | R4 | 4224h | 1267.2h | LTE_CA_B8_B27-Perf | 32 | KT | ilwhan.kim@kt.com | Rel-13 | 62 | LTE_CA_B8_B27-Perf | Issam | CA | RP-151131 |
| 4062 | 1537.4 | **LTE Advanced 3 band Carrier Aggregation (3DL/1UL) for Band 3, Band 8 and Band 27** | 531d? | 2013-12-09 A | 2015-12-15 | 25% | 398.25d? | 2013-12-09 | 2014-12-05 | 261d? | 2670d |  | R4 | 12696h | 2384h | LTE_CA_B3_B8_B27 | 32 | KT | Chungwoo HWANG (cwhwang@kt.com) | Rel-13 | 62 | LTE_CA_B3_B8_B27 | Issam | CA |  |
| 4063 | 1537.4.1 | Core part:LTE Advanced 3 band Carrier Aggregation (3DL/1UL) for Band 3, Band 8 and Band 27 | 528d? | 2013-12-09 A | 2015-12-15 | 25% | 396d? | 2013-12-09 | 2014-12-05 | 261d? | 2670d | finish no earlier than 2015-12-15 | R4 | 4224h | 1056h | LTE_CA_B3_B8_B27-Core | 32 | KT | Chungwoo HWANG (cwhwang@kt.com) | Rel-13 | 62 | LTE_CA_B3_B8_B27-Core | Issam | CA | RP-151131 |
| 4064 | 1537.4.2 | Perf. part:LTE Advanced 3 band Carrier Aggregation (3DL/1UL) for Band 3, Band 8 and Band 27 | 528d? | 2013-12-09 A | 2015-12-15 | 25% | 396d? | 2013-12-09 | 2014-12-05 | 261d? | 2670d | finish no earlier than 2015-12-15 | R4 | 4224h | 1056h | LTE_CA_B3_B8_B27-Perf | 32 | KT | Chungwoo HWANG (cwhwang@kt.com) | Rel-13 | 62 | LTE_CA_B3_B8_B27-Perf | Issam | CA | RP-151131 |
| 4065 | 1537.5 | **LTE Advanced inter-band Carrier Aggregation of Band 7 and Band 22** | 336d? | 2014-03-06 A | 2015-06-15 A | 100% |  | 2014-03-06 | 2014-12-05 | 197d? |  |  | R4 | 8016h | 8016h | LTE_CA_B7_B22 | 32 | Orange, Ericsson | erika.tejedor@ericsson.com | Rel-13 | 63 | LTE_CA_B7_B22 | Issam | CA |  |
| 4066 | 1537.5.1 | Core part:LTE Advanced inter-band Carrier Aggregation of Band 7 and Band 22 | 333d? | 2014-03-06 A | 2015-06-15 A | 100% |  | 2014-03-06 | 2014-12-05 | 197d? |  | finish no earlier than 2015-06-15 | R4 | 2664h | 2664h | LTE_CA_B7_B22-Core | 32 | Orange, Ericsson | erika.tejedor@ericsson.com | Rel-13 | 63 | LTE_CA_B7_B22-Core | Issam | CA | RP-150536 |
| 4067 | 1537.5.2 | Perf. part:LTE Advanced inter-band Carrier Aggregation of Band 7 and Band 22 | 333d? | 2014-03-11 A | 2015-06-15 A | 100% |  | 2014-03-06 | 2014-12-05 | 197d? |  | finish no earlier than 2015-06-15 | R4 | 2664h | 2664h | LTE_CA_B7_B22-Perf | 32 | Orange, Ericsson | erika.tejedor@ericsson.com | Rel-13 | 63 | LTE_CA_B7_B22-Perf | Issam | CA | RP-150536 |

Notes:
- 4044: - / Impacted TSs and TRs: Stage 2
- 4045: Dec.14: 30->65%. Mar15: 75%¦June2015: Compl:75%->100 / Impacted TSs and TRs: New 23.708
- 4046: -¦June2015: Compl:0%->100 / Impacted TSs and TRs: 23.682; 33.187
- 4047: TR 33.8xy will capture requirements, solution alternatives, evaluations and conclusions for the AESE, MONTE and GROUPE WIDs. Dec.14: 0->40%. 3/3/15: 45%.¦June2015: Compl:45%->60¦11/12/15: 60%->100 / Impacted TSs and TRs: New 33.889
- 4048: -¦11/12/15: 0%->100 / Impacted TSs and TRs: 33.187
- 4049: 14/09/15: WID:CP-150402->CP-150487->CP-150576
- 4050: 07/09/15: 0%->35¦14/09/15: WID:CP-150402->CP-150487->CP-150576¦7/12/15: 35%->90¦7/3/16: 90%->100 / Impacted TSs and TRs: 29.154
- 4051: 07/09/15: 0%->40¦14/09/15: WID:CP-150402->CP-150487->CP-150576¦7/12/15: 40%->100 / Impacted TSs and TRs: 29.201; 29.336; 29.230; 29.272; 23.008
- 4052: Acronym changed from "LTE_CA_Rel-13" to "LTE_CA_Rel13"
- 4053: 13/6/16: moved from Rel-14 to Rel-13 (was a mistake)
- 4054: 13/6/16: moved from Rel-14 to Rel-13 (was a mistake)
- 4055: 13/6/16: moved from Rel-14 to Rel-13 (was a mistake)
- 4056: 13/6/16: moved from Rel-14 to Rel-13 (was a mistake)
- 4057: 13/6/16: moved from Rel-14 to Rel-13 (was a mistake)
- 4058: 13/6/16: moved from Rel-14 to Rel-13 (was a mistake)
- 4059: Inter-band CA 2DL/1UL / Impacted TSs and TRs: LTE
- 4060: CD:Thu 18/06/15->Mon 15/06/15¦Compl:10%->10%¦Stat Rep: RP-141084->RP-141732 1st Apr 15: Compl:10%->15% 1st Apr 15: Stat Rep: RP-141732->RP-150013 03/07/15: Compl:15%->30% 03/07/15: CD:Mon 15/06/15->Tue 15/12/15 03/07/15: Stat Rep: RP-150013->RP-15053 / Impacted TSs and TRs: 36.101; 36.104; 36.133; generic 36.851
- 4061: CD:Thu 18/06/15->Mon 15/06/15¦Compl:10%->10%¦Stat Rep: RP-141084->RP-141732 1st Apr 15: Compl:10%->15% 1st Apr 15: Stat Rep: RP-141732->RP-150013 03/07/15: Compl:15%->30% 03/07/15: CD:Mon 15/06/15->Tue 15/12/15 03/07/15: Stat Rep: RP-150013->RP-15053 / Impacted TSs and TRs: 36.141; 36.307
- 4062: Inter-band CA 3DL / Impacted TSs and TRs: LTE
- 4063: CD:Thu 18/06/15->Mon 15/06/15¦Compl:25%->25%¦Stat Rep: RP-141084->RP-141732 1st Apr 15: Compl:25%->30% 1st Apr 15: Stat Rep: RP-141732->RP-150013 03/07/15: Compl:30%->25% 03/07/15: CD:Mon 15/06/15->Tue 15/12/15 03/07/15: Stat Rep: RP-150013->RP-15053 / Impacted TSs and TRs: 36.101; 36.104; 36.133; 36.141; 36.307; new generic 36.853 (3 Band CA with 1UL)
- 4064: CD:Thu 18/06/15->Mon 15/06/15¦Compl:25%->25%¦Stat Rep: RP-141084->RP-141732 1st Apr 15: Compl:25%->30% 1st Apr 15: Stat Rep: RP-141732->RP-150013 03/07/15: Compl:30%->25% 03/07/15: CD:Mon 15/06/15->Tue 15/12/15 03/07/15: Stat Rep: RP-150013->RP-15053 / Impacted TSs and TRs: 36.101; 36.104; 36.133; 36.141; 36.307
- 4065: Inter-band CA 2DL / Impacted TSs and TRs: LTE
- 4066: CD:Thu 11/12/14->Mon 15/06/15¦Compl:10%->10%¦Stat Rep: RP-141084->RP-141732 03/07/15: Compl:10%->100% 03/07/15: Stat Rep: RP-141732->RP-150536 / Impacted TSs and TRs: 36.101; 36.104; 36.133; generic 36.851 (2 Band CA with 1UL).
- 4067: CD:Thu 11/12/14->Mon 15/06/15¦Compl:0%->0%¦Stat Rep: RP-141084->RP-141732 03/07/15: Compl:0%->100% 03/07/15: Stat Rep: RP-141732->RP-150536 / Impacted TSs and TRs: 36.141; 36.307

| ID | WBS | Task | Duration | Start | Finish | Complete | Baseline start | Baseline finish | Baseline duration | Constraint | Resources | Work | Actual work | Acronym | PCG approved | WI rapporteur name | WI rapporteur e-mail | Release | TSG approved | Special Focus Doc | Acronym_3GU_Export | Status Report |
| --- | --- | --- | --- | --- | --- | --- | --- | --- | --- | --- | --- | --- | --- | --- | --- | --- | --- | --- | --- | --- | --- | --- |
| 4068 | 1537.6 | **LTE Advanced 3 Band Carrier Aggregation (3DL/1UL) for Band 2, Band 2 and Band 12** | 262d? | 2014-06-18 A | 2015-06-15 A | 100% | 2014-06-13 | 2015-03-13 | 196d? |  | R4 | 6288h | 6288h | LTE_CA_B2_B2_B12 | 33 | U.S. Cellular | sebastian.thalanany@uscellular.com | Rel-13 | 64 | CA | LTE_CA_B2_B2_B12 |  |
| 4069 | 1537.6.1 | Core part:LTE Advanced 3 Band Carrier Aggregation (3DL/1UL) for Band 2, Band 2 and Band 12 | 262d? | 2014-06-18 A | 2015-06-15 A | 100% | 2014-06-13 | 2014-12-05 | 126d? | finish no earlier than 2015-06-15 | R4 | 2096h | 2096h | LTE_CA_B2_B2_B12-Core | 33 | U.S. Cellular | sebastian.thalanany@uscellular.com | Rel-13 | 64 | CA | LTE_CA_B2_B2_B12-Core | RP-150536 |
| 4070 | 1537.6.2 | Perf. Part:LTE Advanced 3 Band Carrier Aggregation (3DL/1UL) for Band 2, Band 2 and Band 12 | 262d? | 2014-06-18 A | 2015-06-15 A | 100% | 2014-06-13 | 2015-03-13 | 196d? | finish no earlier than 2015-06-15 | R4 | 2096h | 2096h | LTE_CA_B2_B2_B12-Perf | 33 | U.S. Cellular | sebastian.thalanany@uscellular.com | Rel-13 | 64 | CA | LTE_CA_B2_B2_B12-Perf | RP-150536 |
| 4071 | 1537.7 | **LTE Advanced 3 Band Carrier Aggregation (3DL/1UL) of Band 3, Band 3 and Band 8** | 264d? | 2014-06-16 A | 2015-06-15 A | 100% | 2014-06-13 | 2015-06-12 | 261d? |  | R4 | 6304h | 6304h | LTE_CA_B3_B3_B8 | 33 | CHTTL | Po-Han Hsieh (pohanhsieh@cht.com.tw) | Rel-13 | 64 | CA | LTE_CA_B3_B3_B8 |  |
| 4072 | 1537.7.1 | Core part:LTE Advanced 3 Band Carrier Aggregation (3DL/1UL) of Band 3, Band 3 and Band 8 | 262d? | 2014-06-16 A | 2015-06-15 A | 100% | 2014-06-13 | 2015-06-12 | 261d? | finish no earlier than 2015-06-15 | R4 | 2096h | 2096h | LTE_CA_B3_B3_B8-Core | 33 | CHTTL | Po-Han Hsieh (pohanhsieh@cht.com.tw) | Rel-13 | 64 | CA | LTE_CA_B3_B3_B8-Core | RP-150536 |
| 4073 | 1537.7.2 | Perf. Part:LTE Advanced 3 Band Carrier Aggregation (3DL/1UL) of Band 3, Band 3 and Band 8 | 262d? | 2014-06-18 A | 2015-06-15 A | 100% | 2014-06-13 | 2015-06-12 | 261d? | finish no earlier than 2015-06-15 | R4 | 2096h | 2096h | LTE_CA_B3_B3_B8-Perf | 33 | CHTTL | Po-Han Hsieh (pohanhsieh@cht.com.tw) | Rel-13 | 64 | CA | LTE_CA_B3_B3_B8-Perf | RP-150536 |
| 4074 | 1537.8 | **LTE Advanced 3 Band Carrier Aggregation (3DL/1UL) of Band 41, Band 42 and Band 42** | 264d? | 2014-06-16 A | 2015-06-15 A | 100% | 2014-06-13 | 2014-12-05 | 126d? |  | R4 | 6304h | 6304h | LTE_CA_B41_B42_B42 | 33 | Huawei | leo.liuye@huawei.com | Rel-13 | 64 | CA | LTE_CA_B41_B42_B42 |  |
| 4075 | 1537.8.1 | Core part:LTE Advanced 3 Band Carrier Aggregation (3DL/1UL) of Band 41, Band 42 and Band 42 | 262d? | 2014-06-16 A | 2015-06-15 A | 100% | 2014-06-13 | 2014-12-05 | 126d? | finish no earlier than 2015-06-15 | R4 | 2096h | 2096h | LTE_CA_B41_B42_B42-Core | 33 | Huawei | leo.liuye@huawei.com | Rel-13 | 64 | CA | LTE_CA_B41_B42_B42-Core | RP-150536 |
| 4076 | 1537.8.2 | Perf. Part:LTE Advanced 3 Band Carrier Aggregation (3DL/1UL) of Band 41, Band 42 and Band 42 | 262d? | 2014-06-18 A | 2015-06-15 A | 100% | 2014-06-13 | 2014-12-05 | 126d? | finish no earlier than 2015-06-15 | R4 | 2096h | 2096h | LTE_CA_B41_B42_B42-Perf | 33 | Huawei | leo.liuye@huawei.com | Rel-13 | 64 | CA | LTE_CA_B41_B42_B42-Perf | RP-150536 |
| 4077 | 1537.9 | **LTE Advanced inter-band Carrier Aggregation of Band 3 and Band 38** | 198d? | 2014-09-15 A | 2015-06-15 A | 100% | 2014-06-13 | 2015-03-13 | 196d? |  | R4 | 4752h | 4752h | LTE_CA_B3_B38 | 33 | Nokia Networks | iwajlo.angelow@nsn.com | Rel-13 | 65 | CA | LTE_CA_B3_B38 |  |
| 4078 | 1537.9.1 | Core part:LTE Advanced inter-band Carrier Aggregation of Band 3 and Band 38 | 198d? | 2014-09-15 A | 2015-06-15 A | 100% | 2014-06-13 | 2015-03-13 | 196d? | finish no earlier than 2015-06-15 | R4 | 1584h | 1584h | LTE_CA_B3_B38-Core | 33 | Nokia Networks | iwajlo.angelow@nsn.com | Rel-13 | 65 | CA | LTE_CA_B3_B38-Core | RP-150536 |
| 4079 | 1537.9.2 | Perf. Part:LTE Advanced inter-band Carrier Aggregation of Band 3 and Band 38 | 198d? | 2014-09-15 A | 2015-06-15 A | 100% | 2014-06-13 | 2015-03-13 | 196d? | finish no earlier than 2015-06-15 | R4 | 1584h | 1584h | LTE_CA_B3_B38-Perf | 33 | Nokia Networks | iwajlo.angelow@nsn.com | Rel-13 | 65 | CA | LTE_CA_B3_B38-Perf | RP-150536 |
| 4080 | 1537.10 | **LTE Advanced inter-band Carrier Aggregation of Band 2 and Band 28** | 198d? | 2014-09-15 A | 2015-06-15 A | 100% | 2014-06-13 | 2015-03-13 | 196d? |  | R4 | 4752h | 4752h | LTE_CA_B2_B28 | 33 | Huawei | alf.ahlstrom@huawei.com | Rel-13 | 65 | CA | LTE_CA_B2_B28 |  |
| 4081 | 1537.10.1 | Core part:LTE Advanced inter-band Carrier Aggregation of Band 2 and Band 28 | 198d? | 2014-09-15 A | 2015-06-15 A | 100% | 2014-06-13 | 2015-03-13 | 196d? | finish no earlier than 2015-06-15 | R4 | 1584h | 1584h | LTE_CA_B2_B28-Core | 33 | Huawei | alf.ahlstrom@huawei.com | Rel-13 | 65 | CA | LTE_CA_B2_B28-Core | RP-150536 |
| 4082 | 1537.10.2 | Perf. Part:LTE Advanced inter-band Carrier Aggregation of Band 2 and Band 28 | 198d? | 2014-09-15 A | 2015-06-15 A | 100% | 2014-06-13 | 2015-03-13 | 196d? | finish no earlier than 2015-06-15 | R4 | 1584h | 1584h | LTE_CA_B2_B28-Perf | 33 | Huawei | alf.ahlstrom@huawei.com | Rel-13 | 65 | CA | LTE_CA_B2_B28-Perf | RP-150536 |
| 4083 | 1537.11 | **LTE Advanced inter-band Carrier Aggregation of Band 4 and Band 28** | 198d? | 2014-09-15 A | 2015-06-15 A | 100% | 2014-06-13 | 2015-03-13 | 196d? |  | R4 | 4752h | 4752h | LTE_CA_B4_B28 | 33 | Huawei | alf.ahlstrom@huawei.com | Rel-13 | 65 | CA | LTE_CA_B4_B28 |  |
| 4084 | 1537.11.1 | Core part:LTE Advanced inter-band Carrier Aggregation of Band 4 and Band 28 | 198d? | 2014-09-15 A | 2015-06-15 A | 100% | 2014-06-13 | 2015-03-13 | 196d? | finish no earlier than 2015-06-15 | R4 | 1584h | 1584h | LTE_CA_B4_B28-Core | 33 | Huawei | alf.ahlstrom@huawei.com | Rel-13 | 65 | CA | LTE_CA_B4_B28-Core | RP-150536 |
| 4085 | 1537.11.2 | Perf. Part:LTE Advanced inter-band Carrier Aggregation of Band 4 and Band 28 | 198d? | 2014-09-15 A | 2015-06-15 A | 100% | 2014-06-13 | 2015-03-13 | 196d? | finish no earlier than 2015-06-15 | R4 | 1584h | 1584h | LTE_CA_B4_B28-Perf | 33 | Huawei | alf.ahlstrom@huawei.com | Rel-13 | 65 | CA | LTE_CA_B4_B28-Perf | RP-150536 |
| 4086 | 1537.12 | **LTE Advanced inter-band Carrier Aggregation of Band 20 and Band 40** | 330d? | 2014-09-12 A | 2015-12-15 A | 100% | 2014-06-13 | 2015-03-13 | 196d? |  | R4 | 7912h | 7912h | LTE_CA_B20_B40 | 33 | Ericsson | imadur.rahman@ericsson.com | Rel-13 | 65 | CA | LTE_CA_B20_B40 |  |
| 4087 | 1537.12.1 | Core part:LTE Advanced inter-band Carrier Aggregation of Band 20 and Band 40 | 330d? | 2014-09-12 A | 2015-12-15 A | 100% | 2014-06-13 | 2015-03-13 | 196d? | finish no earlier than 2015-12-15 | R4 | 2640h | 2640h | LTE_CA_B20_B40-Core | 33 | Ericsson | imadur.rahman@ericsson.com | Rel-13 | 65 | CA | LTE_CA_B20_B40-Core | RP-151131 |
| 4088 | 1537.12.2 | Perf. Part:LTE Advanced inter-band Carrier Aggregation of Band 20 and Band 40 | 329d? | 2014-09-15 A | 2015-12-15 A | 100% | 2014-06-13 | 2015-03-13 | 196d? | finish no earlier than 2015-12-15 | R4 | 2632h | 2632h | LTE_CA_B20_B40-Perf | 33 | Ericsson | imadur.rahman@ericsson.com | Rel-13 | 65 | CA | LTE_CA_B20_B40-Perf | RP-151131 |
| 4089 | 1537.13 | **LTE Advanced inter-band Carrier Aggregation of Band 1 and Band 40** | 329d? | 2014-09-15 A | 2015-12-15 A | 100% | 2014-06-13 | 2015-03-13 | 196d? |  | R4 | 7896h | 7896h | LTE_CA_B1_B40 | 33 | KT | ilwhan.kim@kt.com | Rel-13 | 65 | CA | LTE_CA_B1_B40 |  |
| 4090 | 1537.13.1 | Core part:LTE Advanced inter-band Carrier Aggregation of Band 1 and Band 40 | 329d? | 2014-09-15 A | 2015-12-15 A | 100% | 2014-06-13 | 2015-03-13 | 196d? | finish no earlier than 2015-12-15 | R4 | 2632h | 2632h | LTE_CA_B1_B40-Core | 33 | KT | ilwhan.kim@kt.com | Rel-13 | 65 | CA | LTE_CA_B1_B40-Core | RP-151131 |
| 4091 | 1537.13.2 | Perf. Part:LTE Advanced inter-band Carrier Aggregation of Band 1 and Band 40 | 329d? | 2014-09-15 A | 2015-12-15 A | 100% | 2014-06-13 | 2015-03-13 | 196d? | finish no earlier than 2015-12-15 | R4 | 2632h | 2632h | LTE_CA_B1_B40-Perf | 33 | KT | ilwhan.kim@kt.com | Rel-13 | 65 | CA | LTE_CA_B1_B40-Perf | RP-151131 |

Notes:
- 4068: Inter-band CA 3DL/1UL / Impacted TSs and TRs: LTE
- 4069: CD:Thu 12/03/15->Sun 15/03/15¦Compl:0%->40%¦Stat Rep: RP-141084->RP-141732 1st Apr 15: Compl:40%->99% 1st Apr 15: CD:Sun 15/03/15->Mon 15/06/15 1st Apr 15: Stat Rep: RP-141732->RP-150013 03/07/15: Compl:99%->100% 03/07/15: Stat Rep: RP-150013->RP-150536 / Impacted TSs and TRs: 36.101; 36.104; 36.133; 36.141; 36.307; generic new Rel-13 TR36.8xy [similar to Rel-12 36.853 (3 Band CA with 1UL)]
- 4070: CD:Thu 18/06/15->Mon 15/06/15¦Compl:0%->10%¦Stat Rep: RP-141084->RP-141732 1st Apr 15: Compl:10%->99% 1st Apr 15: Stat Rep: RP-141732->RP-150013 03/07/15: Compl:99%->100% 03/07/15: Stat Rep: RP-150013->RP-150536 / Impacted TSs and TRs: 36.101; 36.104; 36.133; 36.141; 36.307
- 4071: Inter-band CA 3DL/1UL / Impacted TSs and TRs: LTE
- 4072: ¦WID: RP-142043->RP-141832¦Stat Rep: RP-141084->RP-141732 1st Apr 15: Compl:60%->99% 1st Apr 15: Stat Rep: RP-141732->RP-150013 03/07/15: Compl:99%->100% 03/07/15: WID: RP-141832->RP-150874 03/07/15: Stat Rep: RP-150013->RP-150536 / Impacted TSs and TRs: 36.101; 36.133; generic 36.853 (3 Band CA with 1UL)
- 4073: ¦WID: RP-142043->RP-141832¦Stat Rep: RP-141084->RP-141732 1st Apr 15: Compl:0%->99% 1st Apr 15: Stat Rep: RP-141732->RP-150013 03/07/15: Compl:99%->100% 03/07/15: WID: RP-141832->RP-150874 03/07/15: Stat Rep: RP-150013->RP-150536 / Impacted TSs and TRs: 36.307
- 4074: Inter-band CA 3DL/1UL / Impacted TSs and TRs: LTE
- 4075: CD:Thu 11/12/14->Sun 15/03/15¦Compl:30%->50%¦Stat Rep: RP-141084->RP-141732 1st Apr 15: Compl:50%->60% 1st Apr 15: CD:Sun 15/03/15->Mon 15/06/15 1st Apr 15: Stat Rep: RP-141732->RP-150013 03/07/15: Compl:60%->100% 03/07/15: Stat Rep: RP-150013->RP-15 / Impacted TSs and TRs: 36.101; 36.104; 36.133; generic 36.853 (3 Band CA with 1UL)
- 4076: CD:Thu 11/12/14->Sun 15/03/15¦Compl:0%->0%¦Stat Rep: RP-141084->RP-141732 1st Apr 15: Compl:0%->60% 1st Apr 15: CD:Sun 15/03/15->Mon 15/06/15 1st Apr 15: Stat Rep: RP-141732->RP-150013 03/07/15: Compl:60%->100% 03/07/15: Stat Rep: RP-150013->RP-150536 / Impacted TSs and TRs: 36.141; 36.307
- 4077: Inter-band CA 2DL/1UL / Impacted TSs and TRs: LTE
- 4078: CD:Thu 11/12/14->Sun 15/03/15¦Compl:0%->90%¦Stat Rep: -->RP-141732 1st Apr 15: CD:Sun 15/03/15->Mon 15/06/15 1st Apr 15: Stat Rep: RP-141732->RP-150013 03/07/15: Compl:90%->100% 03/07/15: WID: RP-141129->RP-150717 03/07/15: Stat Rep: RP-150013->RP-15 / Impacted TSs and TRs: 36.101; 36.104; New 36.8xx
- 4079: CD:Thu 11/12/14->Sun 15/03/15¦Compl:0%->90%¦Stat Rep: -->RP-141732 1st Apr 15: CD:Sun 15/03/15->Mon 15/06/15 1st Apr 15: Stat Rep: RP-141732->RP-150013 03/07/15: Compl:90%->100% 03/07/15: WID: RP-141129->RP-150717 03/07/15: Stat Rep: RP-150013->RP-15 / Impacted TSs and TRs: 36.141; 36.307
- 4080: Inter-band CA 2DL/1UL / Impacted TSs and TRs: LTE
- 4081: CD:Fri 11/12/15->Sun 15/03/15¦Compl:0%->50%¦Stat Rep: -->RP-141732 1st Apr 15: Compl:50%->99% 1st Apr 15: CD:Sun 15/03/15->Mon 15/06/15 1st Apr 15: Stat Rep: RP-141732->RP-150013 03/07/15: Compl:99%->100% 03/07/15: Stat Rep: RP-150013->RP-150536 / Impacted TSs and TRs: 36.101; 36.104; New 36.8xx
- 4082: CD:Thu 12/03/15->Sun 15/03/15¦Compl:0%->0%¦Stat Rep: -->RP-141732 1st Apr 15: Compl:0%->99% 1st Apr 15: CD:Sun 15/03/15->Mon 15/06/15 1st Apr 15: Stat Rep: RP-141732->RP-150013 03/07/15: Compl:99%->100% 03/07/15: Stat Rep: RP-150013->RP-150536 / Impacted TSs and TRs: 36.141; 36.307
- 4083: Inter-band CA 2DL/1UL / Impacted TSs and TRs: LTE
- 4084: CD:Fri 11/12/15->Sun 15/03/15¦Compl:0%->35%¦Stat Rep: -->RP-141732 1st Apr 15: Compl:35%->99% 1st Apr 15: CD:Sun 15/03/15->Mon 15/06/15 1st Apr 15: Stat Rep: RP-141732->RP-150013 03/07/15: Compl:99%->100% 03/07/15: Stat Rep: RP-150013->RP-150536 / Impacted TSs and TRs: 36.101; 36.104; New 36.8xx
- 4085: CD:Thu 12/03/15->Sun 15/03/15¦Compl:0%->0%¦Stat Rep: -->RP-141732 1st Apr 15: Compl:0%->99% 1st Apr 15: CD:Sun 15/03/15->Mon 15/06/15 1st Apr 15: Stat Rep: RP-141732->RP-150013 03/07/15: Compl:99%->100% 03/07/15: Stat Rep: RP-150013->RP-150536 / Impacted TSs and TRs: 36.141; 36.307
- 4086: Inter-band CA 2DL/1UL / Impacted TSs and TRs: LTE
- 4087: CD:Wed 11/03/15->Sun 15/03/15¦Compl:0%->30%¦Stat Rep: -->RP-141732 1st Apr 15: Compl:30%->70% 1st Apr 15: CD:Sun 15/03/15->Mon 15/06/15 1st Apr 15: Stat Rep: RP-141732->RP-150013 03/07/15: CD:Mon 15/06/15->Tue 15/09/15 03/07/15: Stat Rep: RP-150013-> / Impacted TSs and TRs: 36.101; 36.104; 36.133; New 36.8xx
- 4088: CD:Thu 12/03/15->Sun 15/03/15¦Compl:0%->0%¦Stat Rep: -->RP-141732 1st Apr 15: CD:Sun 15/03/15->Mon 15/06/15 1st Apr 15: Stat Rep: RP-141732->RP-150013 03/07/15: Compl:0%->70% 03/07/15: CD:Mon 15/06/15->Tue 15/09/15 03/07/15: Stat Rep: RP-150013->RP-1 / Impacted TSs and TRs: 36.141; 36.307
- 4089: Inter-band CA 2DL/1UL / Impacted TSs and TRs: LTE
- 4090: CD:Fri 12/06/15->Mon 15/06/15¦Compl:0%->70%¦Stat Rep: -->RP-141732 1st Apr 15: Compl:70%->80% 1st Apr 15: Stat Rep: RP-141732->RP-150013 03/07/15: Compl:80%->70% 03/07/15: CD:Mon 15/06/15->Tue 15/12/15 03/07/15: Stat Rep: RP-150013->RP-150536 29/09/1 / Impacted TSs and TRs: 36.101; 36.104; 36.133; New 36.8xx
- 4091: CD:Fri 11/12/15->Mon 15/06/15¦Compl:0%->70%¦Stat Rep: -->RP-141732 1st Apr 15: Compl:70%->80% 1st Apr 15: Stat Rep: RP-141732->RP-150013 03/07/15: Compl:80%->70% 03/07/15: CD:Mon 15/06/15->Tue 15/12/15 03/07/15: Stat Rep: RP-150013->RP-150536 29/09/1 / Impacted TSs and TRs: 36.141; 36.307

| ID | WBS | Task | Duration | Start | Finish | Complete | Baseline start | Baseline finish | Baseline duration | Constraint | Resources | Work | Actual work | Acronym | PCG approved | WI rapporteur name | WI rapporteur e-mail | Release | TSG approved | Special Focus Doc | Acronym_3GU_Export | Status Report |
| --- | --- | --- | --- | --- | --- | --- | --- | --- | --- | --- | --- | --- | --- | --- | --- | --- | --- | --- | --- | --- | --- | --- |
| 4092 | 1537.14 | **LTE Advanced inter-band Carrier Aggregation of Band 3 and Band 40** | 198d? | 2014-09-15 A | 2015-06-15 A | 100% | 2014-06-13 | 2015-03-13 | 196d? |  | R4 | 4752h | 4752h | LTE_CA_B3_B40 | 33 | KT | Chungwoo HWANG (cwhwang@kt.com) | Rel-13 | 65 | CA | LTE_CA_B3_B40 |  |
| 4093 | 1537.14.1 | Core part:LTE Advanced inter-band Carrier Aggregation of Band 3 and Band 40 | 198d? | 2014-09-15 A | 2015-06-15 A | 100% | 2014-06-13 | 2015-03-13 | 196d? | finish no earlier than 2015-06-15 | R4 | 1584h | 1584h | LTE_CA_B3_B40-Core | 33 | KT | Chungwoo HWANG (cwhwang@kt.com) | Rel-13 | 65 | CA | LTE_CA_B3_B40-Core | RP-150536 |
| 4094 | 1537.14.2 | Perf. Part:LTE Advanced inter-band Carrier Aggregation of Band 3 and Band 40 | 198d? | 2014-09-15 A | 2015-06-15 A | 100% | 2014-06-13 | 2015-03-13 | 196d? | finish no earlier than 2015-06-15 | R4 | 1584h | 1584h | LTE_CA_B3_B40-Perf | 33 | KT | Chungwoo HWANG (cwhwang@kt.com) | Rel-13 | 65 | CA | LTE_CA_B3_B40-Perf | RP-150536 |
| 4095 | 1537.15 | **LTE Advanced inter-band Carrier Aggregation of Band 20 and Band 31** | 198d? | 2014-09-15 A | 2015-06-15 A | 100% | 2014-06-13 | 2015-03-13 | 196d? |  | R4 | 4752h | 4752h | LTE_CA_B20_B31 | 33 | Huawei | Liu Liehai (liuliehai@huawei.com) | Rel-13 | 65 | CA | LTE_CA_B20_B31 |  |
| 4096 | 1537.15.1 | Core part:LTE Advanced inter-band Carrier Aggregation of Band 20 and Band 31 | 198d? | 2014-09-15 A | 2015-06-15 A | 100% | 2014-06-13 | 2015-03-13 | 196d? | finish no earlier than 2015-06-15 | R4 | 1584h | 1584h | LTE_CA_B20_B31-Core | 33 | Huawei | Liu Liehai (liuliehai@huawei.com) | Rel-13 | 65 | CA | LTE_CA_B20_B31-Core | RP-150536 |
| 4097 | 1537.15.2 | Perf. Part:LTE Advanced inter-band Carrier Aggregation of Band 20 and Band 31 | 198d? | 2014-09-15 A | 2015-06-15 A | 100% | 2014-06-13 | 2015-03-13 | 196d? | finish no earlier than 2015-06-15 | R4 | 1584h | 1584h | LTE_CA_B20_B31-Perf | 33 | Huawei | Liu Liehai (liuliehai@huawei.com) | Rel-13 | 65 | CA | LTE_CA_B20_B31-Perf | RP-150536 |
| 4098 | 1537.16 | **LTE Advanced inter-band Carrier Aggregation of Band 3 and Band 31** | 198d? | 2014-09-15 A | 2015-06-15 A | 100% | 2014-06-13 | 2015-03-13 | 196d? |  | R4 | 4752h | 4752h | LTE_CA_B3_B31 | 33 | Huawei | Liu Liehai (liuliehai@huawei.com) | Rel-13 | 65 | CA | LTE_CA_B3_B31 |  |
| 4099 | 1537.16.1 | Core part:LTE Advanced inter-band Carrier Aggregation of Band 3 and Band 31 | 198d? | 2014-09-15 A | 2015-06-15 A | 100% | 2014-06-13 | 2015-03-13 | 196d? | finish no earlier than 2015-06-15 | R4 | 1584h | 1584h | LTE_CA_B3_B31-Core | 33 | Huawei | Liu Liehai (liuliehai@huawei.com) | Rel-13 | 65 | CA | LTE_CA_B3_B31-Core | RP-150536 |
| 4100 | 1537.16.2 | Perf. Part:LTE Advanced inter-band Carrier Aggregation of Band 3 and Band 31 | 198d? | 2014-09-15 A | 2015-06-15 A | 100% | 2014-06-13 | 2015-03-13 | 196d? | finish no earlier than 2015-06-15 | R4 | 1584h | 1584h | LTE_CA_B3_B31-Perf | 33 | Huawei | Liu Liehai (liuliehai@huawei.com) | Rel-13 | 65 | CA | LTE_CA_B3_B31-Perf | RP-150536 |
| 4101 | 1537.17 | **LTE Advanced inter-band Carrier Aggregation of Band 5 and Band 40** | 199d? | 2014-09-12 A | 2015-06-15 A | 100% | 2014-06-13 | 2015-03-13 | 196d? |  | R4 | 4768h | 4768h | LTE_CA_B5_B40 | 33 | SK Telecom | haesung.park@sk.com | Rel-13 | 65 | CA | LTE_CA_B5_B40 |  |
| 4102 | 1537.17.1 | Core part:LTE Advanced inter-band Carrier Aggregation of Band 5 and Band 40 | 199d? | 2014-09-12 A | 2015-06-15 A | 100% | 2014-06-13 | 2015-03-13 | 196d? | finish no earlier than 2015-06-15 | R4 | 1592h | 1592h | LTE_CA_B5_B40-Core | 33 | SK Telecom | haesung.park@sk.com | Rel-13 | 65 | CA | LTE_CA_B5_B40-Core | RP-150536 |
| 4103 | 1537.17.2 | Perf. Part:LTE Advanced inter-band Carrier Aggregation of Band 5 and Band 40 | 198d? | 2014-09-15 A | 2015-06-15 A | 100% | 2014-06-13 | 2015-03-13 | 196d? | finish no earlier than 2015-06-15 | R4 | 1584h | 1584h | LTE_CA_B5_B40-Perf | 33 | SK Telecom | haesung.park@sk.com | Rel-13 | 65 | CA | LTE_CA_B5_B40-Perf | RP-150536 |
| 4104 | 1537.18 | **LTE Advanced intra-band contiguous Carrier Aggregation in Band 42 for 3DL** | 198d? | 2014-09-15 A | 2015-06-15 A | 100% | 2014-06-13 | 2015-03-13 | 196d? |  | R4 | 4752h | 4752h | LTE_CA_C_B42_3DL | 33 | CATT | Yuexia Song (songyuexia@catt.cn) | Rel-13 | 65 | CA | LTE_CA_C_B42_3DL |  |
| 4105 | 1537.18.1 | Core part: LTE Advanced intra-band contiguous Carrier Aggregation in Band 42 for 3DL | 198d? | 2014-09-15 A | 2015-06-15 A | 100% | 2014-06-13 | 2015-03-13 | 196d? | finish no earlier than 2015-06-15 | R4 | 1584h | 1584h | LTE_CA_C_B42_3DL-Core | 33 | CATT | Yuexia Song (songyuexia@catt.cn) | Rel-13 | 65 | CA | LTE_CA_C_B42_3DL-Core | RP-150536 |
| 4106 | 1537.18.2 | Perf. Part: LTE Advanced intra-band contiguous Carrier Aggregation in Band 42 for 3DL | 198d? | 2014-09-15 A | 2015-06-15 A | 100% | 2014-06-13 | 2015-03-13 | 196d? | finish no earlier than 2015-06-15 | R4 | 1584h | 1584h | LTE_CA_C_B42_3DL-Perf | 33 | CATT | Yuexia Song (songyuexia@catt.cn) | Rel-13 | 65 | CA | LTE_CA_C_B42_3DL-Perf | RP-150536 |
| 4107 | 1537.19 | **LTE Advanced 3 Band Carrier Aggregation (3DL/1UL) of Band 8, Band 41 and Band 41** | 199d? | 2014-09-12 A | 2015-06-15 A | 100% | 2014-06-13 | 2015-03-13 | 196d? |  | R4 | 4768h | 4768h | LTE_CA_B8_B41_B41 | 33 | China Mobile | PAN, Qun (panqun@chinamobile.com) | Rel-13 | 65 | CA | LTE_CA_B8_B41_B41 |  |
| 4108 | 1537.19.1 | Core part:LTE Advanced 3 Band Carrier Aggregation (3DL/1UL) of Band 8, Band 41 and Band 41 | 198d? | 2014-09-15 A | 2015-06-15 A | 100% | 2014-06-13 | 2015-03-13 | 196d? | finish no earlier than 2015-06-15 | R4 | 1584h | 1584h | LTE_CA_B8_B41_B41-Core | 33 | China Mobile | PAN, Qun (panqun@chinamobile.com) | Rel-13 | 65 | CA | LTE_CA_B8_B41_B41-Core | RP-150536 |
| 4109 | 1537.19.2 | Perf. Part:LTE Advanced 3 Band Carrier Aggregation (3DL/1UL) of Band 8, Band 41 and Band 41 | 199d? | 2014-09-12 A | 2015-06-15 A | 100% | 2014-06-13 | 2015-03-13 | 196d? | finish no earlier than 2015-06-15 | R4 | 1592h | 1592h | LTE_CA_B8_B41_B41-Perf | 33 | China Mobile | PAN, Qun (panqun@chinamobile.com) | Rel-13 | 65 | CA | LTE_CA_B8_B41_B41-Perf | RP-150536 |
| 4110 | 1537.20 | **LTE Advanced 3 Band Carrier Aggregation (3DL/1UL) of Band 38, Band 40 and Band 40** | 198d? | 2014-09-15 A | 2015-06-15 A | 100% | 2014-06-13 | 2015-03-13 | 196d? |  | R4 | 4752h | 4752h | LTE_CA_B38_B40_B40 | 33 | Samsung | xutao.zhou@samsung.com | Rel-13 | 65 | CA | LTE_CA_B38_B40_B40 |  |
| 4111 | 1537.20.1 | Core part:LTE Advanced 3 Band Carrier Aggregation (3DL/1UL) of Band 38, Band 40 and Band 40 | 198d? | 2014-09-15 A | 2015-06-15 A | 100% | 2014-06-13 | 2015-03-13 | 196d? | finish no earlier than 2015-06-15 | R4 | 1584h | 1584h | LTE_CA_B38_B40_B40-Core | 33 | Samsung | xutao.zhou@samsung.com | Rel-13 | 65 | CA | LTE_CA_B38_B40_B40-Core | RP-150536 |
| 4112 | 1537.20.2 | Perf. Part:LTE Advanced 3 Band Carrier Aggregation (3DL/1UL) of Band 38, Band 40 and Band 40 | 198d? | 2014-09-15 A | 2015-06-15 A | 100% | 2014-06-13 | 2015-03-13 | 196d? | finish no earlier than 2015-06-15 | R4 | 1584h | 1584h | LTE_CA_B38_B40_B40-Perf | 33 | Samsung | xutao.zhou@samsung.com | Rel-13 | 65 | CA | LTE_CA_B38_B40_B40-Perf | RP-150536 |
| 4113 | 1537.21 | **LTE Advanced 3 Band Carrier Aggregation (3DL/1UL) of Band 2, Band 5 and Band 29** | 198d? | 2014-09-15 A | 2015-06-15 A | 100% | 2014-06-13 | 2015-03-13 | 196d? |  | R4 | 4752h | 4752h | LTE_CA_B2_B5_B29 | 33 | Huawei | SHAN Huiping (shanhuiping@huawei.com) | Rel-13 | 65 | CA | LTE_CA_B2_B5_B29 |  |
| 4114 | 1537.21.1 | Core part:LTE Advanced 3 Band Carrier Aggregation (3DL/1UL) of Band 2, Band 5 and Band 29 | 198d? | 2014-09-15 A | 2015-06-15 A | 100% | 2014-06-13 | 2015-03-13 | 196d? | finish no earlier than 2015-06-15 | R4 | 1584h | 1584h | LTE_CA_B2_B5_B29-Core | 33 | Huawei | SHAN Huiping (shanhuiping@huawei.com) | Rel-13 | 65 | CA | LTE_CA_B2_B5_B29-Core | RP-150536 |
| 4115 | 1537.21.2 | Perf. Part:LTE Advanced 3 Band Carrier Aggregation (3DL/1UL) of Band 2, Band 5 and Band 29 | 198d? | 2014-09-15 A | 2015-06-15 A | 100% | 2014-06-13 | 2015-03-13 | 196d? | finish no earlier than 2015-06-15 | R4 | 1584h | 1584h | LTE_CA_B2_B5_B29-Perf | 33 | Huawei | SHAN Huiping (shanhuiping@huawei.com) | Rel-13 | 65 | CA | LTE_CA_B2_B5_B29-Perf | RP-150536 |

Notes:
- 4092: Inter-band CA 2DL/1UL / Impacted TSs and TRs: LTE
- 4093: CD:Fri 11/12/15->Mon 15/06/15¦Compl:0%->70%¦Stat Rep: -->RP-141732 1st Apr 15: Compl:70%->80% 1st Apr 15: Stat Rep: RP-141732->RP-150013 03/07/15: Compl:80%->100% 03/07/15: WID: RP-141674->RP-150832 03/07/15: Stat Rep: RP-150013->RP-150536 / Impacted TSs and TRs: 36.101; 36.104; 36.133; New 36.8xx
- 4094: CD:Fri 12/06/15->Mon 15/06/15¦Compl:0%->70%¦Stat Rep: -->RP-141732 1st Apr 15: Compl:70%->80% 1st Apr 15: Stat Rep: RP-141732->RP-150013 03/07/15: Compl:80%->100% 03/07/15: WID: RP-141674->RP-150832 03/07/15: Stat Rep: RP-150013->RP-150536 / Impacted TSs and TRs: 36.141; 36.307
- 4095: Inter-band CA 2DL/1UL / Impacted TSs and TRs: LTE
- 4096: ¦WID: RP-142043->RP-142007¦Stat Rep: -->RP-141732 1st Apr 15: Compl:75%->99% 1st Apr 15: CD:Sun 15/03/15->Mon 15/06/15 1st Apr 15: Stat Rep: RP-141732->RP-150013 03/07/15: Compl:99%->100% 03/07/15: Stat Rep: RP-150013->RP-150536 / Impacted TSs and TRs: 36.101; 36.104; New 36.8xx
- 4097: ¦WID: RP-142043->RP-142007¦Stat Rep: -->RP-141732 1st Apr 15: Compl:0%->99% 1st Apr 15: CD:Sun 15/03/15->Mon 15/06/15 1st Apr 15: Stat Rep: RP-141732->RP-150013 03/07/15: Compl:99%->100% 03/07/15: Stat Rep: RP-150013->RP-150536 / Impacted TSs and TRs: 36.141; 36.307
- 4098: Inter-band CA 2DL/1UL / Impacted TSs and TRs: LTE
- 4099: CD:Fri 11/12/15->Sun 15/03/15¦Compl:0%->50%¦Stat Rep: -->RP-141732 1st Apr 15: Compl:50%->75% 1st Apr 15: CD:Sun 15/03/15->Mon 15/06/15 1st Apr 15: WID: RP-141337->RP-150318 1st Apr 15: Stat Rep: RP-141732->RP-150013 03/07/15: Compl:75%->100% 03/07/1 / Impacted TSs and TRs: 36.101; 36.104; New 36.8xx
- 4100: CD:Thu 12/03/15->Sun 15/03/15¦Compl:0%->0%¦Stat Rep: -->RP-141732 1st Apr 15: CD:Sun 15/03/15->Mon 15/06/15 1st Apr 15: WID: RP-141337->RP-150318 1st Apr 15: Stat Rep: RP-141732->RP-150013 03/07/15: Compl:0%->100% 03/07/15: Stat Rep: RP-150013->RP-15 / Impacted TSs and TRs: 36.141; 36.307
- 4101: Inter-band CA 2DL/1UL / Impacted TSs and TRs: LTE
- 4102: ¦WID: RP-142043->RP-141888¦Stat Rep: -->RP-141732 1st Apr 15: Compl:0%->80% 1st Apr 15: WID: RP-141888->RP-150285 1st Apr 15: Stat Rep: RP-141732->RP-150013 03/07/15: Compl:80%->100% 03/07/15: Stat Rep: RP-150013->RP-150536 / Impacted TSs and TRs: 36.101; 36.104; New 36.8xx
- 4103: ¦WID: RP-142043->RP-141888¦Stat Rep: -->RP-141732 1st Apr 15: Compl:0%->80% 1st Apr 15: WID: RP-141888->RP-150285 1st Apr 15: Stat Rep: RP-141732->RP-150013 03/07/15: Compl:80%->100% 03/07/15: Stat Rep: RP-150013->RP-150536 / Impacted TSs and TRs: 36.141; 36.307
- 4104: Intra-band contig. CA 3DL / Impacted TSs and TRs: LTE
- 4105: CD:Fri 12/06/15->Mon 15/06/15¦Compl:0%->70%¦Stat Rep: -->RP-141732 1st Apr 15: Compl:70%->99% 1st Apr 15: WID: RP-141677->RP-150319 1st Apr 15: Stat Rep: RP-141732->RP-150013 03/07/15: Compl:99%->100% 03/07/15: WID: RP-150319->RP-151027 03/07/15: Sta / Impacted TSs and TRs: 36.101; 36.104; 36.133; New 36.833-5-42
- 4106: CD:Fri 12/06/15->Mon 15/06/15¦Compl:0%->0%¦Stat Rep: -->RP-141732 1st Apr 15: Compl:0%->99% 1st Apr 15: WID: RP-141677->RP-150319 1st Apr 15: Stat Rep: RP-141732->RP-150013 03/07/15: Compl:99%->100% 03/07/15: WID: RP-150319->RP-151027 03/07/15: Stat / Impacted TSs and TRs: 36.141; 36.307
- 4107: Inter-band CA 3DL/1UL / Impacted TSs and TRs: LTE
- 4108: ¦WID: RP-142043->RP-141845¦Stat Rep: -->RP-141732 1st Apr 15: Compl:80%->99% 1st Apr 15: CD:Sun 15/03/15->Mon 15/06/15 1st Apr 15: Stat Rep: RP-141732->RP-150013 03/07/15: Compl:99%->100% 03/07/15: Stat Rep: RP-150013->RP-150536 / Impacted TSs and TRs: 36.101; 36.104; 36.133; New 36.8xx
- 4109: ¦WID: RP-142043->RP-141845¦Stat Rep: -->RP-141732 1st Apr 15: Compl:0%->99% 1st Apr 15: CD:Sun 15/03/15->Mon 15/06/15 1st Apr 15: Stat Rep: RP-141732->RP-150013 03/07/15: Compl:99%->100% 03/07/15: Stat Rep: RP-150013->RP-150536 / Impacted TSs and TRs: 36.141; 36.307
- 4110: Inter-band CA 3DL/1UL / Impacted TSs and TRs: LTE
- 4111: CD:Fri 12/06/15->Mon 15/06/15¦Compl:0%->0%¦Stat Rep: -->RP-141732 1st Apr 15: Compl:0%->70% 1st Apr 15: Stat Rep: RP-141732->RP-150013 03/07/15: Compl:70%->100% 03/07/15: Stat Rep: RP-150013->RP-150536 / Impacted TSs and TRs: 36.101; 36.104; 36.133; New 36.8xx
- 4112: CD:Fri 12/06/15->Mon 15/06/15¦Compl:0%->0%¦Stat Rep: -->RP-141732 1st Apr 15: Compl:0%->70% 1st Apr 15: Stat Rep: RP-141732->RP-150013 03/07/15: Compl:70%->100% 03/07/15: Stat Rep: RP-150013->RP-150536 / Impacted TSs and TRs: 36.141; 36.307
- 4113: Inter-band CA 3DL/1UL / Impacted TSs and TRs: LTE
- 4114: CD:Fri 11/12/15->Mon 15/06/15¦Compl:0%->50%¦Stat Rep: -->RP-141732 1st Apr 15: Compl:50%->99% 1st Apr 15: Stat Rep: RP-141732->RP-150013 03/07/15: Compl:99%->100% 03/07/15: Stat Rep: RP-150013->RP-150536 / Impacted TSs and TRs: 36.101; 36.104; 36.133; New 36.8xy (inter-band CA 2DL/1UL (introduce CA_B5-B29); New 36.8xz (inter-band CA 3DL/1UL)
- 4115: CD:Fri 12/06/15->Mon 15/06/15¦Compl:0%->0%¦Stat Rep: -->RP-141732 1st Apr 15: Compl:0%->99% 1st Apr 15: Stat Rep: RP-141732->RP-150013 03/07/15: Compl:99%->100% 03/07/15: Stat Rep: RP-150013->RP-150536 / Impacted TSs and TRs: 36.141; 36.307

| ID | WBS | Task | Duration | Start | Finish | Complete | Constraint | Resources | Work | Actual work | Acronym | PCG approved | WI rapporteur name | WI rapporteur e-mail | Release | TSG approved | Status Report |
| --- | --- | --- | --- | --- | --- | --- | --- | --- | --- | --- | --- | --- | --- | --- | --- | --- | --- |
| 4116 | 1537.22 | **LTE Carrier Aggregation Enhancement Beyond 5 Carriers** | 981d? | 2014-12-15 A | 2018-09-14 A | 100% |  |  | 9416h | 9416h | LTE_CA_enh_b5C | 34 | Nokia Networks | Nokia | Rel-13 | 66 |  |
| 4117 | 1537.22.1 | Core part: LTE Carrier Aggregation Enhancement Beyond 5 Carriers | 262d? | 2014-12-15 A | 2015-12-15 A | 100% | finish no earlier than 2015-12-15 | R1 | 2096h | 2096h | LTE_CA_enh_b5C-Core | 34 | Nokia Networks | Nokia | Rel-13 | 66 | RP-151285 |
| 4118 | 1537.22.2 | Perf. part: LTE Carrier Aggregation Enhancement Beyond 5 Carriers | 393d? | 2014-12-15 A | 2016-06-15 A | 100% | finish no earlier than 2016-06-15 | R4 | 3144h | 3144h | LTE_CA_enh_b5C-Perf | 34 | Nokia Networks | Nokia | Rel-13 | 66 | RP-151285 |
| 4119 | 1537.22.3 | UE Conformance Test Aspects - LTE Carrier Aggregation Enhancement Beyond 5 Carriers: PUCCH on Scell | 522d? | 2016-09-15 A | 2018-09-14 A | 100% | finish no earlier than 2018-09-15 | R5 | 4176h | 4176h | LTE_CA_enh_b5C_PUCCH-UEConTest | 37 | Huawei |  | Rel-13 | 73 |  |
| 4120 | 1537.23 | **HSPA Dual-Band UL carrier aggregation** | 327d? | 2014-12-15 A | 2016-03-15 A | 100% |  | R4 | 7328h | 7328h | HSUPA_DB_MC | 34 | Qualcomm | Qualcomm | Rel-13 | 66 |  |
| 4121 | 1537.23.1 | Core part: HSPA Dual-Band UL carrier aggregation | 262d? | 2014-12-15 A | 2015-12-15 A | 100% | finish no earlier than 2015-12-15 | R4 | 2096h | 2096h | HSUPA_DB_MC-Core | 34 | Qualcomm | Qualcomm | Rel-13 | 66 | RP-151281 |
| 4122 | 1537.23.2 | Perf. part: HSPA Dual-Band UL carrier aggregation | 327d? | 2014-12-15 A | 2016-03-15 A | 100% | finish no earlier than 2016-03-15 | R4 | 2616h | 2616h | HSUPA_DB_MC-Perf | 34 | Qualcomm | Qualcomm | Rel-13 | 66 | RP-151281 |
| 4123 | 1537.24 | **LTE Advanced inter-band Carrier Aggregation of Band 25 and Band 26** | 131d? | 2014-12-15 A | 2015-06-15 A | 100% |  | R4 | 3144h | 3144h | LTE_CA_B25_B26 | 34 | Sprint | Sprint | Rel-13 | 66 |  |
| 4124 | 1537.24.1 | Core part:LTE Advanced inter-band Carrier Aggregation of Band 25 and Band 26 | 131d? | 2014-12-15 A | 2015-06-15 A | 100% | finish no earlier than 2015-06-15 | R4 | 1048h | 1048h | LTE_CA_B25_B26-Core | 34 | Sprint | Sprint | Rel-13 | 66 | RP-150536 |
| 4125 | 1537.24.2 | Perf. part:LTE Advanced inter-band Carrier Aggregation of Band 25 and Band 26 | 131d? | 2014-12-15 A | 2015-06-15 A | 100% | finish no earlier than 2015-06-15 | R4 | 1048h | 1048h | LTE_CA_B25_B26-Perf | 34 | Sprint | Sprint | Rel-13 | 66 | RP-150536 |
| 4126 | 1537.25 | **LTE Advanced inter-band Carrier Aggregation of Band 3 and Band 41** | 262d? | 2014-12-15 A | 2015-12-15 A | 100% |  | R4 | 6288h | 6288h | LTE_CA_B3_B41 | 34 | China Telecom | China Telecom | Rel-13 | 66 |  |
| 4127 | 1537.25.1 | Core part:LTE Advanced inter-band Carrier Aggregation of Band 3 and Band 41 | 262d? | 2014-12-15 A | 2015-12-15 A | 100% | finish no earlier than 2015-12-15 | R4 | 2096h | 2096h | LTE_CA_B3_B41-Core | 34 | China Telecom | China Telecom | Rel-13 | 66 | RP-151131 |
| 4128 | 1537.25.2 | Perf. part:LTE Advanced inter-band Carrier Aggregation of Band 3 and Band 41 | 262d? | 2014-12-15 A | 2015-12-15 A | 100% | finish no earlier than 2015-12-15 | R4 | 2096h | 2096h | LTE_CA_B3_B41-Perf | 34 | China Telecom | China Telecom | Rel-13 | 66 | RP-151131 |
| 4129 | 1537.26 | **LTE Advanced 3 band Carrier Aggregation (3DL/1UL) of Band 1, Band 3 and Band 3** | 197d? | 2014-12-15 A | 2015-09-15 A | 100% |  | R4 | 4728h | 4728h | LTE_CA_B1_B3_B3 | 34 | China Unicom | China Unicom | Rel-13 | 66 |  |
| 4130 | 1537.26.1 | Core part:LTE Advanced 3 band Carrier Aggregation (3DL/1UL) of Band 1, Band 3 and Band 3 | 197d? | 2014-12-15 A | 2015-09-15 A | 100% | finish no earlier than 2015-09-15 | R4 | 1576h | 1576h | LTE_CA_B1_B3_B3-Core | 34 | China Unicom | China Unicom | Rel-13 | 66 | RP-151131 |
| 4131 | 1537.26.2 | Perf. part:LTE Advanced 3 band Carrier Aggregation (3DL/1UL) of Band 1, Band 3 and Band 3 | 197d? | 2014-12-15 A | 2015-09-15 A | 100% | finish no earlier than 2015-09-15 | R4 | 1576h | 1576h | LTE_CA_B1_B3_B3-Perf | 34 | China Unicom | China Unicom | Rel-13 | 66 | RP-151131 |
| 4132 | 1537.27 | **LTE Advanced 3 Band Carrier Aggregation (3DL/1UL) of Band 1, Band 19 and Band 28** | 197d? | 2014-12-15 A | 2015-09-15 A | 100% |  | R4 | 4728h | 4728h | LTE_CA_B1_B19_B28 | 34 | NTT DOCOMO | NTT DOCOMO | Rel-13 | 66 |  |
| 4133 | 1537.27.1 | Core part:LTE Advanced 3 Band Carrier Aggregation (3DL/1UL) of Band 1, Band 19 and Band 28 | 197d? | 2014-12-15 A | 2015-09-15 A | 100% | finish no earlier than 2015-09-15 | R4 | 1576h | 1576h | LTE_CA_B1_B19_B28-Core | 34 | NTT DOCOMO | NTT DOCOMO | Rel-13 | 66 | RP-151131 |
| 4134 | 1537.27.2 | Perf. part:LTE Advanced 3 Band Carrier Aggregation (3DL/1UL) of Band 1, Band 19 and Band 28 | 197d? | 2014-12-15 A | 2015-09-15 A | 100% | finish no earlier than 2015-09-15 | R4 | 1576h | 1576h | LTE_CA_B1_B19_B28-Perf | 34 | NTT DOCOMO | NTT DOCOMO | Rel-13 | 66 | RP-151131 |
| 4135 | 1537.28 | **LTE Advanced 3 Band Carrier Aggregation (3DL/1UL) of Band 21, Band 42 and Band 42** | 131d? | 2014-12-15 A | 2015-06-15 A | 100% |  | R4 | 3144h | 3144h | LTE_CA_B21_B42_B42 | 34 | NTT DOCOMO | NTT DOCOMO | Rel-13 | 66 |  |
| 4136 | 1537.28.1 | Core part:LTE Advanced 3 Band Carrier Aggregation (3DL/1UL) of Band 21, Band 42 and Band 42 | 131d? | 2014-12-15 A | 2015-06-15 A | 100% | finish no earlier than 2015-06-15 | R4 | 1048h | 1048h | LTE_CA_B21_B42_B42-Core | 34 | NTT DOCOMO | NTT DOCOMO | Rel-13 | 66 | RP-150536 |
| 4137 | 1537.28.2 | Perf. part:LTE Advanced 3 Band Carrier Aggregation (3DL/1UL) of Band 21, Band 42 and Band 42 | 131d? | 2014-12-15 A | 2015-06-15 A | 100% | finish no earlier than 2015-06-15 | R4 | 1048h | 1048h | LTE_CA_B21_B42_B42-Perf | 34 | NTT DOCOMO | NTT DOCOMO | Rel-13 | 66 | RP-150536 |
| 4138 | 1537.29 | **LTE Advanced 3 Band Carrier Aggregation (3DL/1UL) of Band 7, Band 40 and Band 40** | 197d? | 2014-12-15 A | 2015-09-15 A | 100% |  | R4 | 4728h | 4728h | LTE_CA_B7_B40_B40 | 34 | ZTE | ZTE | Rel-13 | 66 |  |
| 4139 | 1537.29.1 | Core part:LTE Advanced 3 Band Carrier Aggregation (3DL/1UL) of Band 7, Band 40 and Band 40 | 197d? | 2014-12-15 A | 2015-09-15 A | 100% | finish no earlier than 2015-09-15 | R4 | 1576h | 1576h | LTE_CA_B7_B40_B40-Core | 34 | ZTE | ZTE | Rel-13 | 66 | RP-151131 |
| 4140 | 1537.29.2 | Perf. part:LTE Advanced 3 Band Carrier Aggregation (3DL/1UL) of Band 7, Band 40 and Band 40 | 197d? | 2014-12-15 A | 2015-09-15 A | 100% | finish no earlier than 2015-09-15 | R4 | 1576h | 1576h | LTE_CA_B7_B40_B40-Perf | 34 | ZTE | ZTE | Rel-13 | 66 | RP-151131 |

Notes:
- 4116: FCD: 06/16->12/15, Rel-14?->Rel-13
- 4117: FCD: 06/16->12/15, Rel-14?->Rel-13 1st Apr 15: Compl:0%->10% 1st Apr 15: WID: RP-142286->RP-150277 1st Apr 15: Stat Rep: ->RP-150272 03/07/15: Compl:10%->40% 03/07/15: WID: RP-150277->RP-150771 03/07/15: Stat Rep: RP-150272->RP-150769 29/09/15: Compl:4
- 4118: 1st Apr 15: WID: RP-142286->RP-150277 1st Apr 15: Stat Rep: ->RP-150272 03/07/15: WID: RP-150277->RP-150771 03/07/15: Stat Rep: RP-150272->RP-150769 29/09/15: Stat Rep: RP-150769->RP-151285¦22/3/16: ;
- 4119: ¦20/12/16: Compl:0%->5%19/6/17: Compl:5%->8%¦19/9/17: Compl:8%->15%¦8/1/18: 27/3/18; 14/1/20: WID:RP-171764->RP-192558; 14/1/20: 20%->100
- 4121: 1st Apr 15: Compl:0%->10% 1st Apr 15: WID: RP-142237->RP-150129 1st Apr 15: Stat Rep: ->RP-150127 03/07/15: Compl:10%->40% 03/07/15: Stat Rep: RP-150127->RP-150761 29/09/15: Compl:40%->50% 29/09/15: Stat Rep: RP-150761->RP-151281¦
- 4122: 1st Apr 15: WID: RP-142237->RP-150129 1st Apr 15: Stat Rep: ->RP-150127 03/07/15: Stat Rep: RP-150127->RP-150761 29/09/15: Stat Rep: RP-150761->RP-1512811/1/16: Compl:0%->90% ¦
- 4124: 1st Apr 15: Compl:0%->95% 1st Apr 15: CD:Tue 15/12/15->Mon 15/06/15 1st Apr 15: WID: RP-142020->RP-150115 1st Apr 15: Stat Rep: ->RP-150013 03/07/15: Compl:95%->100% 03/07/15: Stat Rep: RP-150013->RP-150536
- 4125: 1st Apr 15: Compl:0%->95% 1st Apr 15: CD:Tue 15/12/15->Mon 15/06/15 1st Apr 15: WID: RP-142020->RP-150115 1st Apr 15: Stat Rep: ->RP-150013 03/07/15: Compl:95%->100% 03/07/15: Stat Rep: RP-150013->RP-150536
- 4127: 1st Apr 15: Compl:0%->20% 1st Apr 15: Stat Rep: ->RP-150013 03/07/15: Compl:20%->65% 03/07/15: Stat Rep: RP-150013->RP-150536 29/09/15: CD:Tue 15/09/15->Tue 15/12/15 29/09/15: WID: RP-142239->RP-151446 29/09/15: Stat Rep: RP-150536->RP-151131¦29/09/1
- 4128: 1st Apr 15: Compl:0%->20% 1st Apr 15: Stat Rep: ->RP-150013 03/07/15: Compl:20%->65% 03/07/15: Stat Rep: RP-150013->RP-150536 29/09/15: CD:Tue 15/09/15->Tue 15/12/15 29/09/15: WID: RP-142239->RP-151446 29/09/15: Stat Rep: RP-150536->RP-151131¦29/09/1
- 4130: 1st Apr 15: Compl:0%->50% 1st Apr 15: Stat Rep: ->RP-150013 03/07/15: Compl:50%->90% 03/07/15: CD:Mon 15/06/15->Tue 15/09/15 03/07/15: Stat Rep: RP-150013->RP-150536 29/09/15: Compl:90%->100% 29/09/15: Stat Rep: RP-150536->RP-151131
- 4131: 03/07/15: Compl:0%->90% 03/07/15: CD:Mon 15/06/15->Tue 15/09/15 03/07/15: Stat Rep: ->RP-150536 29/09/15: Compl:90%->100% 29/09/15: Stat Rep: RP-150536->RP-151131
- 4133: 1st Apr 15: Compl:0%->50% 1st Apr 15: Stat Rep: ->RP-150013 03/07/15: Compl:50%->90% 03/07/15: CD:Mon 15/06/15->Tue 15/09/15 03/07/15: WID: RP-141791->RP-150639 03/07/15: Stat Rep: RP-150013->RP-150536 29/09/15: Compl:90%->100% 29/09/15: Stat Rep: RP-
- 4134: 03/07/15: CD:Mon 15/06/15->Tue 15/09/15 03/07/15: WID: RP-141791->RP-150639 03/07/15: Stat Rep: ->RP-150536 29/09/15: Compl:0%->100% 29/09/15: Stat Rep: RP-150536->RP-151131
- 4136: 1st Apr 15: Compl:0%->90% 1st Apr 15: Stat Rep: ->RP-150013 03/07/15: Compl:90%->100% 03/07/15: WID: RP-141792->RP-150640 03/07/15: Stat Rep: RP-150013->RP-150536
- 4137: 03/07/15: Compl:0%->100% 03/07/15: WID: RP-141792->RP-150640 03/07/15: Stat Rep: ->RP-150536
- 4139: 1st Apr 15: Compl:0%->40% 1st Apr 15: Stat Rep: ->RP-150013 03/07/15: Compl:40%->75% 03/07/15: CD:Mon 15/06/15->Tue 15/09/15 03/07/15: WID: RP-141802->RP-150614 03/07/15: Stat Rep: RP-150013->RP-150536 29/09/15: Compl:75%->100% 29/09/15: Stat Rep: RP-
- 4140: 1st Apr 15: Compl:0%->40% 1st Apr 15: Stat Rep: ->RP-150013 03/07/15: Compl:40%->75% 03/07/15: CD:Mon 15/06/15->Tue 15/09/15 03/07/15: WID: RP-141802->RP-150614 03/07/15: Stat Rep: RP-150013->RP-150536 29/09/15: Compl:75%->100% 29/09/15: Stat Rep: RP-

| ID | WBS | Task | Duration | Start | Finish | Complete | Remaining | Total slack | Constraint | Resources | Work | Actual work | Acronym | PCG approved | WI rapporteur name | WI rapporteur e-mail | Release | TSG approved | Status Report |
| --- | --- | --- | --- | --- | --- | --- | --- | --- | --- | --- | --- | --- | --- | --- | --- | --- | --- | --- | --- |
| 4141 | 1537.30 | **LTE Advanced 3 band Carrier Aggregation (3DL/1UL) of Band 1, Band 8 and Band 28** | 327d? | 2014-12-15 A | 2016-03-15 | 40% | 196.2d? | 2605d |  | R4 | 7848h | 2723.2h | LTE_CA_B1_B8_B28 | 34 | Softbank Mobile | Softbank Mobile | Rel-13 | 66 |  |
| 4142 | 1537.30.1 | Core part:LTE Advanced 3 band Carrier Aggregation (3DL/1UL) of Band 1, Band 8 and Band 28 | 327d? | 2014-12-15 A | 2016-03-15 | 40% | 196.2d? | 2605d | finish no earlier than 2016-03-15 | R4 | 2616h | 1046.4h | LTE_CA_B1_B8_B28-Core | 34 | Softbank Mobile | Softbank Mobile | Rel-13 | 66 | RP-151131 |
| 4143 | 1537.30.2 | Perf. part:LTE Advanced 3 band Carrier Aggregation (3DL/1UL) of Band 1, Band 8 and Band 28 | 327d? | 2014-12-15 A | 2016-03-15 | 40% | 196.2d? | 2605d | finish no earlier than 2016-03-15 | R4 | 2616h | 1046.4h | LTE_CA_B1_B8_B28-Perf | 34 | Softbank Mobile | Softbank Mobile | Rel-13 | 66 | RP-151131 |
| 4144 | 1537.31 | **LTE Advanced 3 Band Carrier Aggregation (3DL/1UL) of Band 3, Band 7 and Band 7** | 131d? | 2014-12-15 A | 2015-06-15 A | 100% |  |  |  | R4 | 3144h | 3144h | LTE_CA_B3_B7_B7_Bwset | 34 | Ericsson | Ericsson | Rel-13 | 66 |  |
| 4145 | 1537.31.1 | Core part: Additional bandwidth combination set for LTE Advanced 3 Band Carrier Aggregation (3DL/1UL) of Band 3, Band 7 and Band 7 | 131d? | 2014-12-15 A | 2015-06-15 A | 100% |  |  | finish no earlier than 2015-06-15 | R4 | 1048h | 1048h | LTE_CA_B3_B7_B7_Bwset-Core | 34 | Ericsson | Ericsson | Rel-13 | 66 | RP-150536 |
| 4146 | 1537.31.2 | Perf. Part: Additional bandwidth combination set for LTE Advanced 3 Band Carrier Aggregation (3DL/1UL) of Band 3, Band 7 and Band 7 | 131d? | 2014-12-15 A | 2015-06-15 A | 100% |  |  | finish no earlier than 2015-06-15 | R4 | 1048h | 1048h | LTE_CA_B3_B7_B7_BWset-Perf | 34 | Ericsson | Ericsson | Rel-13 | 66 | RP-150536 |
| 4147 | 1537.32 | **LTE Advanced 3 Band Carrier Aggregation (3DL/1UL) of Band 7, Band 7 and Band 28** | 131d? | 2014-12-15 A | 2015-06-15 A | 100% |  |  |  | R4 | 3144h | 3144h | LTE_CA_B7_B7_B28 | 34 | Ericsson | Ericsson | Rel-13 | 66 |  |
| 4148 | 1537.32.1 | Core part:LTE Advanced 3 Band Carrier Aggregation (3DL/1UL) of Band 7, Band 7 and Band 28 | 131d? | 2014-12-15 A | 2015-06-15 A | 100% |  |  | finish no earlier than 2015-06-15 | R4 | 1048h | 1048h | LTE_CA_B7_B7_B28-Core | 34 | Ericsson | Ericsson | Rel-13 | 66 | RP-150536 |
| 4149 | 1537.32.2 | Perf. part:LTE Advanced 3 Band Carrier Aggregation (3DL/1UL) of Band 7, Band 7 and Band 28 | 131d? | 2014-12-15 A | 2015-06-15 A | 100% |  |  | finish no earlier than 2015-06-15 | R4 | 1048h | 1048h | LTE_CA_B7_B7_B28-Perf | 34 | Ericsson | Ericsson | Rel-13 | 66 | RP-150536 |
| 4150 | 1537.33 | **LTE Advanced 3 band Carrier Aggregation (3DL/1UL) of Band 1, Band 3 and Band 40** | 262d? | 2014-12-15 A | 2015-12-15 A | 100% |  |  |  | R4 | 6288h | 6288h | LTE_CA_B1_B3_B40 | 34 | KT | KT | Rel-13 | 66 |  |
| 4151 | 1537.33.1 | Core part:LTE Advanced 3 band Carrier Aggregation (3DL/1UL) of Band 1, Band 3 and Band 40 | 262d? | 2014-12-15 A | 2015-12-15 A | 100% |  |  | finish no earlier than 2015-12-15 | R4 | 2096h | 2096h | LTE_CA_B1_B3_B40-Core | 34 | KT | KT | Rel-13 | 66 | RP-151131 |
| 4152 | 1537.33.2 | Perf. part:LTE Advanced 3 band Carrier Aggregation (3DL/1UL) of Band 1, Band 3 and Band 40 | 262d? | 2014-12-15 A | 2015-12-15 A | 100% |  |  | finish no earlier than 2015-12-15 | R4 | 2096h | 2096h | LTE_CA_B1_B3_B40-Perf | 34 | KT | KT | Rel-13 | 66 | RP-151131 |
| 4153 | 1537.34 | **LTE Advanced 3 band Carrier Aggregation (3DL/1UL) of Band 1, Band 8 and Band 40** | 262d? | 2014-12-15 A | 2015-12-15 A | 100% |  |  |  | R4 | 6288h | 6288h | LTE_CA_B1_B8_B40 | 34 | KT | KT | Rel-13 | 66 |  |
| 4154 | 1537.34.1 | Core part:LTE Advanced 3 band Carrier Aggregation (3DL/1UL) of Band 1, Band 8 and Band 40 | 262d? | 2014-12-15 A | 2015-12-15 A | 100% |  |  | finish no earlier than 2015-12-15 | R4 | 2096h | 2096h | LTE_CA_B1_B8_B40-Core | 34 | KT | KT | Rel-13 | 66 | RP-151131 |
| 4155 | 1537.34.2 | Perf. part:LTE Advanced 3 band Carrier Aggregation (3DL/1UL) of Band 1, Band 8 and Band 40 | 262d? | 2014-12-15 A | 2015-12-15 A | 100% |  |  | finish no earlier than 2015-12-15 | R4 | 2096h | 2096h | LTE_CA_B1_B8_B40-Perf | 34 | KT | KT | Rel-13 | 66 | RP-151131 |
| 4156 | 1537.35 | **LTE Advanced 3 band Carrier Aggregation (3DL/1UL) of Band 3, Band 8 and Band 40** | 262d? | 2014-12-15 A | 2015-12-15 A | 100% |  |  |  | R4 | 6288h | 6288h | LTE_CA_B3_B8_B40 | 34 | KT | KT | Rel-13 | 66 |  |
| 4157 | 1537.35.1 | Core part:LTE Advanced 3 band Carrier Aggregation (3DL/1UL) of Band 3, Band 8 and Band 40 | 262d? | 2014-12-15 A | 2015-12-15 A | 100% |  |  | finish no earlier than 2015-12-15 | R4 | 2096h | 2096h | LTE_CA_B3_B8_B40-Core | 34 | KT | KT | Rel-13 | 66 | RP-151131 |
| 4158 | 1537.35.2 | Perf. part:LTE Advanced 3 band Carrier Aggregation (3DL/1UL) of Band 3, Band 8 and Band 40 | 262d? | 2014-12-15 A | 2015-12-15 A | 100% |  |  | finish no earlier than 2015-12-15 | R4 | 2096h | 2096h | LTE_CA_B3_B8_B40-Perf | 34 | KT | KT | Rel-13 | 66 | RP-151131 |
| 4159 | 1537.36 | **LTE Advanced 3 Band Carrier Aggregation (3DL) of Band 3, Band 7 and Band 8** | 131d? | 2014-12-15 A | 2015-06-15 A | 100% |  |  |  | R4 | 3144h | 3144h | LTE_CA_B3_B7_B8 | 34 | Ericsson | Ericsson | Rel-13 | 66 |  |
| 4160 | 1537.36.1 | Core part:LTE Advanced 3 Band Carrier Aggregation (3DL) of Band 3, Band 7 and Band 8 | 131d? | 2014-12-15 A | 2015-06-15 A | 100% |  |  | finish no earlier than 2015-06-15 | R4 | 1048h | 1048h | LTE_CA_B3_B7_B8-Core | 34 | Ericsson | Ericsson | Rel-13 | 66 | RP-150536 |
| 4161 | 1537.36.2 | Perf. part:LTE Advanced 3 Band Carrier Aggregation (3DL) of Band 3, Band 7 and Band 8 | 131d? | 2014-12-15 A | 2015-06-15 A | 100% |  |  | finish no earlier than 2015-06-15 | R4 | 1048h | 1048h | LTE_CA_B3_B7_B8-Perf | 34 | Ericsson | Ericsson | Rel-13 | 66 | RP-150536 |
| 4162 | 1537.37 | **LTE Advanced 3 Band Carrier Aggregation (3DL/1UL) of Band 1, Band 3 and Band 28** | 131d? | 2014-12-15 A | 2015-06-15 A | 100% |  |  |  | R4 | 3144h | 3144h | LTE_CA_B1_B3_B28 | 34 | Nokia Networks | Nokia Networks | Rel-13 | 66 |  |
| 4163 | 1537.37.1 | Core part:LTE Advanced 3 Band Carrier Aggregation (3DL/1UL) of Band 1, Band 3 and Band 28 | 131d? | 2014-12-15 A | 2015-06-15 A | 100% |  |  | finish no earlier than 2015-06-15 | R4 | 1048h | 1048h | LTE_CA_B1_B3_B28-Core | 34 | Nokia Networks | Nokia Networks | Rel-13 | 66 | RP-150536 |
| 4164 | 1537.37.2 | Perf. part:LTE Advanced 3 Band Carrier Aggregation (3DL/1UL) of Band 1, Band 3 and Band 28 | 131d? | 2014-12-15 A | 2015-06-15 A | 100% |  |  | finish no earlier than 2015-06-15 | R4 | 1048h | 1048h | LTE_CA_B1_B3_B28-Perf | 34 | Nokia Networks | Nokia Networks | Rel-13 | 66 | RP-150536 |

Notes:
- 4142: 1st Apr 15: Compl:0%->20% 1st Apr 15: WID: RP-141826->RP-150447 1st Apr 15: Stat Rep: ->RP-150013 03/07/15: Compl:20%->40% 03/07/15: Stat Rep: RP-150013->RP-150536 29/09/15: CD:Tue 15/09/15->Tue 15/12/15 29/09/15: Stat Rep: RP-150536->RP-151131
- 4143: 1st Apr 15: Compl:0%->20% 1st Apr 15: WID: RP-141826->RP-150447 1st Apr 15: Stat Rep: ->RP-150013 03/07/15: Compl:20%->40% 03/07/15: Stat Rep: RP-150013->RP-150536 29/09/15: CD:Tue 15/09/15->Tue 15/12/15 29/09/15: Stat Rep: RP-150536->RP-151131
- 4144: Acronym changed from LTE_CA_B3_B7_B7
- 4145: Acronym changed from LTE_CA_B3_B7_B7-Core 1st Apr 15: Compl:0%->99% 1st Apr 15: CD:Sun 15/03/15->Mon 15/06/15 1st Apr 15: Stat Rep: ->RP-150013 03/07/15: Compl:99%->100% 03/07/15: Stat Rep: RP-150013->RP-150536
- 4146: Acronym changed from LTE_CA_B3_B7_B7-Perf 1st Apr 15: Compl:0%->99% 1st Apr 15: CD:Sun 15/03/15->Mon 15/06/15 1st Apr 15: Stat Rep: ->RP-150013 03/07/15: Compl:99%->100% 03/07/15: Stat Rep: RP-150013->RP-150536
- 4148: 1st Apr 15: Compl:0%->99% 1st Apr 15: CD:Sun 15/03/15->Mon 15/06/15 1st Apr 15: Stat Rep: ->RP-150013 03/07/15: Compl:99%->100% 03/07/15: Stat Rep: RP-150013->RP-150536
- 4149: 1st Apr 15: Compl:0%->99% 1st Apr 15: CD:Sun 15/03/15->Mon 15/06/15 1st Apr 15: Stat Rep: ->RP-150013 03/07/15: Compl:99%->100% 03/07/15: Stat Rep: RP-150013->RP-150536
- 4151: 1st Apr 15: Compl:0%->10% 1st Apr 15: Stat Rep: ->RP-150013 03/07/15: Compl:10%->60% 03/07/15: CD:Tue 15/09/15->Tue 15/12/15 03/07/15: Stat Rep: RP-150013->RP-150536 29/09/15: Compl:60%->80% 29/09/15: WID: RP-141946->RP-151258 29/09/15: Stat Rep: RP-1
- 4152: 1st Apr 15: Compl:0%->10% 1st Apr 15: Stat Rep: ->RP-150013 03/07/15: Compl:10%->60% 03/07/15: CD:Tue 15/09/15->Tue 15/12/15 03/07/15: Stat Rep: RP-150013->RP-150536 29/09/15: Compl:60%->80% 29/09/15: WID: RP-141946->RP-151258 29/09/15: Stat Rep: RP-1
- 4154: 1st Apr 15: Compl:0%->10% 1st Apr 15: Stat Rep: ->RP-150013 03/07/15: Compl:10%->60% 03/07/15: CD:Tue 15/09/15->Tue 15/12/15 03/07/15: Stat Rep: RP-150013->RP-150536 29/09/15: Compl:60%->80% 29/09/15: WID: RP-141947->RP-151259 29/09/15: Stat Rep: RP-1
- 4155: 1st Apr 15: Compl:0%->10% 1st Apr 15: Stat Rep: ->RP-150013 03/07/15: Compl:10%->60% 03/07/15: CD:Tue 15/09/15->Tue 15/12/15 03/07/15: Stat Rep: RP-150013->RP-150536 29/09/15: Compl:60%->80% 29/09/15: WID: RP-141947->RP-151259 29/09/15: Stat Rep: RP-1
- 4157: 1st Apr 15: Compl:0%->10% 1st Apr 15: Stat Rep: ->RP-150013 03/07/15: Compl:10%->60% 03/07/15: CD:Tue 15/09/15->Tue 15/12/15 03/07/15: Stat Rep: RP-150013->RP-150536 29/09/15: Compl:60%->95% 29/09/15: WID: RP-141949->RP-151261 29/09/15: Stat Rep: RP-1
- 4158: 1st Apr 15: Compl:0%->10% 1st Apr 15: Stat Rep: ->RP-150013 03/07/15: Compl:10%->60% 03/07/15: CD:Tue 15/09/15->Tue 15/12/15 03/07/15: Stat Rep: RP-150013->RP-150536 29/09/15: Compl:60%->90% 29/09/15: WID: RP-141949->RP-151261 29/09/15: Stat Rep: RP-1
- 4160: 1st Apr 15: Compl:0%->95% 1st Apr 15: Stat Rep: ->RP-150013 03/07/15: Compl:95%->100% 03/07/15: Stat Rep: RP-150013->RP-150536
- 4161: 1st Apr 15: Compl:0%->99% 1st Apr 15: Stat Rep: ->RP-150013 03/07/15: Compl:99%->100% 03/07/15: Stat Rep: RP-150013->RP-150536
- 4163: 1st Apr 15: Compl:0%->99% 1st Apr 15: CD:Sun 15/03/15->Mon 15/06/15 1st Apr 15: Stat Rep: ->RP-150013 03/07/15: Compl:99%->100% 03/07/15: WID: RP-142038->RP-150719 03/07/15: Stat Rep: RP-150013->RP-150536
- 4164: 1st Apr 15: Compl:0%->99% 1st Apr 15: CD:Sun 15/03/15->Mon 15/06/15 1st Apr 15: Stat Rep: ->RP-150013 03/07/15: Compl:99%->100% 03/07/15: WID: RP-142038->RP-150719 03/07/15: Stat Rep: RP-150013->RP-150536

| ID | WBS | Task | Duration | Start | Finish | Complete | Remaining | Total slack | Constraint | Resources | Work | Actual work | Acronym | PCG approved | WI rapporteur name | WI rapporteur e-mail | Release | TSG approved | Status Report |
| --- | --- | --- | --- | --- | --- | --- | --- | --- | --- | --- | --- | --- | --- | --- | --- | --- | --- | --- | --- |
| 4165 | 1537.38 | **LTE Advanced 3 band Carrier Aggregation (3DL/1UL) of Band 3, Band 8 and Band 28** | 327d? | 2014-12-15 A | 2016-03-15 | 40% | 196.2d? | 2605d |  | R4 | 7848h | 2332.07h | LTE_CA_B3_B8_B28 | 34 | Softbank Mobile | Softbank Mobile | Rel-13 | 66 |  |
| 4166 | 1537.38.1 | Core part:LTE Advanced 3 band Carrier Aggregation (3DL/1UL) of Band 3, Band 8 and Band 28 | 327d? | 2014-12-15 A | 2016-03-15 | 40% | 196.2d? | 2605d | finish no earlier than 2016-03-15 | R4 | 2616h | 1046.4h | LTE_CA_B3_B8_B28-Core | 34 | Softbank Mobile | Softbank Mobile | Rel-13 | 66 | RP-151131 |
| 4167 | 1537.38.2 | Perf. part:LTE Advanced 3 band Carrier Aggregation (3DL/1UL) of Band 3, Band 8 and Band 28 | 327d? | 2014-12-15 A | 2016-03-15 | 40% | 196.2d? | 2605d | finish no earlier than 2016-03-15 | R4 | 2616h | 1046.4h | LTE_CA_B3_B8_B28-Perf | 34 | Softbank Mobile | Softbank Mobile | Rel-13 | 66 | RP-151131 |
| 4168 | 1537.39 | **LTE Advanced 3 Band Carrier Aggregation (3DL/1UL) of Band 8, Band 42 and Band 42** | 327d? | 2014-12-15 A | 2016-03-15 A | 100% |  |  |  | R4 | 7848h | 7848h | LTE_CA_B8_B42_B42 | 34 | Softbank Mobile | Softbank Mobile | Rel-13 | 66 |  |
| 4169 | 1537.39.1 | Core part:LTE Advanced 3 Band Carrier Aggregation (3DL/1UL) of Band 8, Band 42 and Band 42 | 327d? | 2014-12-15 A | 2016-03-15 A | 100% |  |  | finish no earlier than 2016-03-15 | R4 | 2616h | 2616h | LTE_CA_B8_B42_B42-Core | 34 | Softbank Mobile | Softbank Mobile | Rel-13 | 66 | RP-151131 |
| 4170 | 1537.39.2 | Perf. part:LTE Advanced 3 Band Carrier Aggregation (3DL/1UL) of Band 8, Band 42 and Band 42 | 327d? | 2014-12-15 A | 2016-03-15 A | 100% |  |  | finish no earlier than 2016-03-15 | R4 | 2616h | 2616h | LTE_CA_B8_B42_B42-Perf | 34 | Softbank Mobile | Softbank Mobile | Rel-13 | 66 | RP-151131 |
| 4171 | 1537.40 | **LTE Advanced 3 Band Carrier Aggregation (3DL/1UL) of Band 28, Band 40 and Band 40** | 262d? | 2014-12-15 A | 2015-12-15 A | 100% |  |  |  | R4 | 6288h | 6288h | LTE_CA_B28_B40_B40 | 34 | Huawei | Huawei | Rel-13 | 66 |  |
| 4172 | 1537.40.1 | Core part:LTE Advanced 3 Band Carrier Aggregation (3DL/1UL) of Band 28, Band 40 and Band 40 | 262d? | 2014-12-15 A | 2015-12-15 A | 100% |  |  | finish no earlier than 2015-12-15 | R4 | 2096h | 2096h | LTE_CA_B28_B40_B40-Core | 34 | Huawei | Huawei | Rel-13 | 66 | RP-151131 |
| 4173 | 1537.40.2 | Perf. part:LTE Advanced 3 Band Carrier Aggregation (3DL/1UL) of Band 28, Band 40 and Band 40 | 262d? | 2014-12-15 A | 2015-12-15 A | 100% |  |  | finish no earlier than 2015-12-15 | R4 | 2096h | 2096h | LTE_CA_B28_B40_B40-Perf | 34 | Huawei | Huawei | Rel-13 | 66 | RP-151131 |
| 4174 | 1537.41 | **LTE Advanced 3 Band Carrier Aggregation (3DL/1UL) of Band 3, Band 40 and Band 40** | 131d? | 2014-12-15 A | 2015-06-15 A | 100% |  |  |  | R4 | 3144h | 3144h | LTE_CA_B3_B40_B40 | 34 | Huawei | Huawei | Rel-13 | 66 |  |
| 4175 | 1537.41.1 | Core part:LTE Advanced 3 Band Carrier Aggregation (3DL/1UL) of Band 3, Band 40 and Band 40 | 131d? | 2014-12-15 A | 2015-06-15 A | 100% |  |  | finish no earlier than 2015-06-15 | R4 | 1048h | 1048h | LTE_CA_B3_B40_B40-Core | 34 | Huawei | Huawei | Rel-13 | 66 | RP-150536 |
| 4176 | 1537.41.2 | Perf. part:LTE Advanced 3 Band Carrier Aggregation (3DL/1UL) of Band 3, Band 40 and Band 40 | 131d? | 2014-12-15 A | 2015-06-15 A | 100% |  |  | finish no earlier than 2015-06-15 | R4 | 1048h | 1048h | LTE_CA_B3_B40_B40-Perf | 34 | Huawei | Huawei | Rel-13 | 66 | RP-150536 |
| 4177 | 1537.42 | **LTE Advanced 3 Band Carrier Aggregation (3DL/1UL) of Band 1, Band 7 and Band 28** | 131d? | 2014-12-15 A | 2015-06-15 A | 100% |  |  |  | R4 | 3144h | 3144h | LTE_CA_B1_B7_B28 | 34 | Huawei | Huawei | Rel-13 | 66 |  |
| 4178 | 1537.42.1 | Core part:LTE Advanced 3 Band Carrier Aggregation (3DL/1UL) of Band 1, Band 7 and Band 28 | 131d? | 2014-12-15 A | 2015-06-15 A | 100% |  |  | finish no earlier than 2015-06-15 | R4 | 1048h | 1048h | LTE_CA_B1_B7_B28-Core | 34 | Huawei | Huawei | Rel-13 | 66 | RP-150536 |
| 4179 | 1537.42.2 | Perf. part:LTE Advanced 3 Band Carrier Aggregation (3DL/1UL) of Band 1, Band 7 and Band 28 | 131d? | 2014-12-15 A | 2015-06-15 A | 100% |  |  | finish no earlier than 2015-06-15 | R4 | 1048h | 1048h | LTE_CA_B1_B7_B28-Perf | 34 | Huawei | Huawei | Rel-13 | 66 | RP-150536 |
| 4180 | 1537.43 | **LTE Advanced 3 Band Carrier Aggregation (3DL/1UL) of Band 1, Band 3 and Band 7** | 262d? | 2014-12-15 A | 2015-12-15 A | 100% |  |  |  | R4 | 6288h | 6288h | LTE_CA_B1_B3_B7 | 34 | Huawei | Huawei | Rel-13 | 66 |  |
| 4181 | 1537.43.1 | Core part:LTE Advanced 3 Band Carrier Aggregation (3DL/1UL) of Band 1, Band 3 and Band 7 | 262d? | 2014-12-15 A | 2015-12-15 A | 100% |  |  | finish no earlier than 2015-12-15 | R4 | 2096h | 2096h | LTE_CA_B1_B3_B7-Core | 34 | Huawei | Huawei | Rel-13 | 66 | RP-151131 |
| 4182 | 1537.43.2 | Perf. part:LTE Advanced 3 Band Carrier Aggregation (3DL/1UL) of Band 1, Band 3 and Band 7 | 262d? | 2014-12-15 A | 2015-12-15 A | 100% |  |  | finish no earlier than 2015-12-15 | R4 | 2096h | 2096h | LTE_CA_B1_B3_B7-Perf | 34 | Huawei | Huawei | Rel-13 | 66 | RP-151131 |
| 4183 | 1537.44 | **LTE Advanced 3 Band Carrier Aggregation (3DL/1UL) of Band 3, Band 3 and Band 5** | 131d? | 2014-12-15 A | 2015-06-15 A | 100% |  |  |  | R4 | 3144h | 3144h | LTE_CA_B3_B3_B5 | 34 | Intel | Intel | Rel-13 | 66 |  |
| 4184 | 1537.44.1 | Core part:LTE Advanced 3 Band Carrier Aggregation (3DL/1UL) of Band 3, Band 3 and Band 5 | 131d? | 2014-12-15 A | 2015-06-15 A | 100% |  |  | finish no earlier than 2015-09-15 | R4 | 1048h | 1048h | LTE_CA_B3_B3_B5-Core | 34 | Intel | Intel | Rel-13 | 66 | RP-150536 |
| 4185 | 1537.44.2 | Perf. part:LTE Advanced 3 Band Carrier Aggregation (3DL/1UL) of Band 3, Band 3 and Band 5 | 131d? | 2014-12-15 A | 2015-06-15 A | 100% |  |  | finish no earlier than 2015-09-15 | R4 | 1048h | 1048h | LTE_CA_B3_B3_B5-Perf | 34 | Intel | Intel | Rel-13 | 66 | RP-150536 |
| 4186 | 1537.45 | **LTE Advanced 3 Band Carrier Aggregation (3DL/1UL) of Band 3, Band 7 and Band 28** | 131d? | 2014-12-15 A | 2015-06-15 A | 100% |  |  |  | R4 | 3144h | 3144h | LTE_CA_B3_B7_B28 | 34 | Ericsson | Ericsson | Rel-13 | 66 |  |
| 4187 | 1537.45.1 | Core part:LTE Advanced 3 Band Carrier Aggregation (3DL/1UL) of Band 3, Band 7 and Band 28 | 131d? | 2014-12-15 A | 2015-06-15 A | 100% |  |  | finish no earlier than 2015-06-15 | R4 | 1048h | 1048h | LTE_CA_B3_B7_B28-Core | 34 | Ericsson | Ericsson | Rel-13 | 66 | RP-150536 |
| 4188 | 1537.45.2 | Perf. part:LTE Advanced 3 Band Carrier Aggregation (3DL/1UL) of Band 3, Band 7 and Band 28 | 131d? | 2014-12-15 A | 2015-06-15 A | 100% |  |  | finish no earlier than 2015-06-15 | R4 | 1048h | 1048h | LTE_CA_B3_B7_B28-Perf | 34 | Ericsson | Ericsson | Rel-13 | 66 | RP-150536 |

Notes:
- 4166: 1st Apr 15: Compl:0%->20% 1st Apr 15: CD:Tue 15/12/15->Tue 15/09/15 1st Apr 15: Stat Rep: ->RP-150013 03/07/15: Compl:20%->40% 03/07/15: Stat Rep: RP-150013->RP-150536 29/09/15: CD:Tue 15/09/15->Tue 15/12/15 29/09/15: Stat Rep: RP-150536->RP-151131¦
- 4167: 1st Apr 15: Compl:0%->20% 1st Apr 15: Stat Rep: ->RP-150013 03/07/15: Compl:20%->40% 03/07/15: Stat Rep: RP-150013->RP-150536 29/09/15: CD:Tue 15/09/15->Tue 15/12/15 29/09/15: Stat Rep: RP-150536->RP-151131
- 4169: 1st Apr 15: Compl:0%->20% 1st Apr 15: CD:Tue 15/12/15->Mon 15/06/15 1st Apr 15: Stat Rep: ->RP-150013 03/07/15: Compl:20%->40% 03/07/15: CD:Mon 15/06/15->Tue 15/09/15 03/07/15: Stat Rep: RP-150013->RP-150536 29/09/15: CD:Tue 15/09/15->Tue 15/12/15 29
- 4170: 1st Apr 15: Compl:0%->20% 1st Apr 15: Stat Rep: ->RP-150013 03/07/15: Compl:20%->40% 03/07/15: CD:Mon 15/06/15->Tue 15/09/15 03/07/15: Stat Rep: RP-150013->RP-150536 29/09/15: CD:Tue 15/09/15->Tue 15/12/15 29/09/15: Stat Rep: RP-150536->RP-151131;
- 4172: 1st Apr 15: Compl:0%->30% 1st Apr 15: CD:Tue 15/12/15->Mon 15/06/15 1st Apr 15: WID: RP-142206->RP-150233 1st Apr 15: Stat Rep: ->RP-150013 03/07/15: Compl:30%->60% 03/07/15: CD:Mon 15/06/15->Tue 15/12/15 03/07/15: WID: RP-150233->RP-150676 03/07/15:
- 4173: 1st Apr 15: WID: RP-142206->RP-150233 1st Apr 15: Stat Rep: ->RP-150013 03/07/15: CD:Mon 15/06/15->Tue 15/12/15 03/07/15: WID: RP-150233->RP-150676 03/07/15: Stat Rep: RP-150013->RP-150536 29/09/15: Stat Rep: RP-150536->RP-151131¦
- 4175: 1st Apr 15: Compl:0%->50% 1st Apr 15: CD:Tue 15/12/15->Mon 15/06/15 1st Apr 15: Stat Rep: ->RP-150013 03/07/15: Compl:50%->100% 03/07/15: WID: RP-142207->RP-151071 03/07/15: Stat Rep: RP-150013->RP-150536
- 4176: 03/07/15: Compl:0%->100% 03/07/15: WID: RP-142207->RP-151071 03/07/15: Stat Rep: ->RP-150536
- 4178: 1st Apr 15: Compl:0%->50% 1st Apr 15: CD:Tue 15/12/15->Mon 15/06/15 1st Apr 15: WID: RP-142208->RP-150234 1st Apr 15: Stat Rep: ->RP-150013 03/07/15: Compl:50%->100% 03/07/15: Stat Rep: RP-150013->RP-150536
- 4179: 1st Apr 15: WID: RP-142208->RP-150234 1st Apr 15: Stat Rep: ->RP-150013 03/07/15: Compl:0%->100% 03/07/15: Stat Rep: RP-150013->RP-150536
- 4181: 1st Apr 15: Compl:0%->30% 1st Apr 15: CD:Tue 15/12/15->Mon 15/06/15 1st Apr 15: Stat Rep: ->RP-150013 03/07/15: Compl:30%->40% 03/07/15: CD:Mon 15/06/15->Tue 15/09/15 03/07/15: Stat Rep: RP-150013->RP-150536 29/09/15: Compl:40%->50% 29/09/15: CD:Tue 1
- 4182: 03/07/15: CD:Mon 15/06/15->Tue 15/09/15 03/07/15: Stat Rep: ->RP-150536 29/09/15: CD:Tue 15/09/15->Tue 15/12/15 29/09/15: Stat Rep: RP-150536->RP-151131
- 4184: 1st Apr 15: Compl:0%->10% 1st Apr 15: Stat Rep: ->RP-150013 03/07/15: Compl:10%->100% 03/07/15: CD:Tue 15/09/15->Mon 15/06/15 03/07/15: Stat Rep: RP-150013->RP-150536
- 4185: 03/07/15: Compl:0%->100% 03/07/15: CD:Tue 15/09/15->Mon 15/06/15 03/07/15: Stat Rep: ->RP-150536
- 4187: 1st Apr 15: Compl:0%->99% 1st Apr 15: CD:Sun 15/03/15->Mon 15/06/15 1st Apr 15: Stat Rep: ->RP-150013 03/07/15: Compl:99%->100% 03/07/15: Stat Rep: RP-150013->RP-150536
- 4188: 1st Apr 15: Compl:0%->99% 1st Apr 15: CD:Sun 15/03/15->Mon 15/06/15 1st Apr 15: Stat Rep: ->RP-150013 03/07/15: Compl:99%->100% 03/07/15: Stat Rep: RP-150013->RP-150536

| ID | WBS | Task | Duration | Start | Finish | Complete | Constraint | Resources | Work | Actual work | Acronym | PCG approved | WI rapporteur name | WI rapporteur e-mail | Release | TSG approved | Status Report |
| --- | --- | --- | --- | --- | --- | --- | --- | --- | --- | --- | --- | --- | --- | --- | --- | --- | --- |
| 4189 | 1537.46 | **LTE Advanced 4 Band Carrier Aggregation (4DL/1UL) of Band 2, Band 2, Band 12 and Band 30** | 262d? | 2014-12-15 A | 2015-12-15 A | 100% |  | R4 | 6288h | 6288h | LTE_CA_B2_B2_B12_B30 | 34 | AT&T | AT&T | Rel-13 | 66 |  |
| 4190 | 1537.46.1 | Core part:LTE Advanced 4 Band Carrier Aggregation (4DL/1UL) of Band 2, Band 2, Band 12 and Band 30 | 262d? | 2014-12-15 A | 2015-12-15 A | 100% | finish no earlier than 2015-12-15 | R4 | 2096h | 2096h | LTE_CA_B2_B2_B12_B30-Core | 34 | AT&T | AT&T | Rel-13 | 66 | RP-151131 |
| 4191 | 1537.46.2 | Perf. part:LTE Advanced 4 Band Carrier Aggregation (4DL/1UL) of Band 2, Band 2, Band 12 and Band 30 | 262d? | 2014-12-15 A | 2015-12-15 A | 100% | finish no earlier than 2015-12-15 | R4 | 2096h | 2096h | LTE_CA_B2_B2_B12_B30-Perf | 34 | AT&T | AT&T | Rel-13 | 66 | RP-151131 |
| 4192 | 1537.47 | **LTE Advanced 4 Band Carrier Aggregation (4DL/1UL) of Band 2, Band 2, Band 5 and Band 30** | 262d? | 2014-12-15 A | 2015-12-15 A | 100% |  | R4 | 6288h | 6288h | LTE_CA_B2_B2_B5_B30 | 34 | AT&T | AT&T | Rel-13 | 66 |  |
| 4193 | 1537.47.1 | Core part:LTE Advanced 4 Band Carrier Aggregation (4DL/1UL) of Band 2, Band 2, Band 5 and Band 30 | 262d? | 2014-12-15 A | 2015-12-15 A | 100% | finish no earlier than 2015-12-15 | R4 | 2096h | 2096h | LTE_CA_B2_B2_B5_B30-Core | 34 | AT&T | AT&T | Rel-13 | 66 | RP-151131 |
| 4194 | 1537.47.2 | Perf. part:LTE Advanced 4 Band Carrier Aggregation (4DL/1UL) of Band 2, Band 2, Band 5 and Band 30 | 262d? | 2014-12-15 A | 2015-12-15 A | 100% | finish no earlier than 2015-12-15 | R4 | 2096h | 2096h | LTE_CA_B2_B2_B5_B30-Perf | 34 | AT&T | AT&T | Rel-13 | 66 | RP-151131 |
| 4195 | 1537.48 | **LTE Advanced 4 Band Carrier Aggregation (4DL/1UL) of Band 2, Band 2 Band 29 and Band 30** | 262d? | 2014-12-15 A | 2015-12-15 A | 100% |  | R4 | 6288h | 6288h | LTE_CA_B2_B2_B29_B30 | 34 | AT&T | AT&T | Rel-13 | 66 |  |
| 4196 | 1537.48.1 | Core part:LTE Advanced 4 Band Carrier Aggregation (4DL/1UL) of Band 2, Band 2 Band 29 and Band 30 | 262d? | 2014-12-15 A | 2015-12-15 A | 100% | finish no earlier than 2015-12-15 | R4 | 2096h | 2096h | LTE_CA_B2_B2_B29_B30-Core | 34 | AT&T | AT&T | Rel-13 | 66 | RP-151131 |
| 4197 | 1537.48.2 | Perf. part:LTE Advanced 4 Band Carrier Aggregation (4DL/1UL) of Band 2, Band 2 Band 29 and Band 30 | 262d? | 2014-12-15 A | 2015-12-15 A | 100% | finish no earlier than 2015-12-15 | R4 | 2096h | 2096h | LTE_CA_B2_B2_B29_B30-Perf | 34 | AT&T | AT&T | Rel-13 | 66 | RP-151131 |
| 4198 | 1537.49 | **LTE Advanced 4 Band Carrier Aggregation (4DL/1UL) of Band 2, Band 4, Band 12 and Band 30** | 262d? | 2014-12-15 A | 2015-12-15 A | 100% |  | R4 | 6288h | 6288h | LTE_CA_B2_B4_B12_B30 | 34 | AT&T | AT&T | Rel-13 | 66 |  |
| 4199 | 1537.49.1 | Core part:LTE Advanced 4 Band Carrier Aggregation (4DL/1UL) of Band 2, Band 4, Band 12 and Band 30 | 262d? | 2014-12-15 A | 2015-12-15 A | 100% | finish no earlier than 2015-12-15 | R4 | 2096h | 2096h | LTE_CA_B2_B4_B12_B30-Core | 34 | AT&T | AT&T | Rel-13 | 66 | RP-151131 |
| 4200 | 1537.49.2 | Perf. part:LTE Advanced 4 Band Carrier Aggregation (4DL/1UL) of Band 2, Band 4, Band 12 and Band 30 | 262d? | 2014-12-15 A | 2015-12-15 A | 100% | finish no earlier than 2015-12-15 | R4 | 2096h | 2096h | LTE_CA_B2_B4_B12_B30-Perf | 34 | AT&T | AT&T | Rel-13 | 66 | RP-151131 |
| 4201 | 1537.50 | **LTE Advanced 4 Band Carrier Aggregation (4DL/1UL) of Band 2, Band 4, Band 5 and Band 30** | 262d? | 2014-12-15 A | 2015-12-15 A | 100% |  | R4 | 6288h | 6288h | LTE_CA_B2_B4_B5_B30 | 34 | AT&T | AT&T | Rel-13 | 66 |  |
| 4202 | 1537.50.1 | Core part:LTE Advanced 4 Band Carrier Aggregation (4DL/1UL) of Band 2, Band 4, Band 5 and Band 30 | 262d? | 2014-12-15 A | 2015-12-15 A | 100% | finish no earlier than 2015-12-15 | R4 | 2096h | 2096h | LTE_CA_B2_B4_B5_B30-Core | 34 | AT&T | AT&T | Rel-13 | 66 | RP-151131 |
| 4203 | 1537.50.2 | Perf. part:LTE Advanced 4 Band Carrier Aggregation (4DL/1UL) of Band 2, Band 4, Band 5 and Band 30 | 262d? | 2014-12-15 A | 2015-12-15 A | 100% | finish no earlier than 2015-12-15 | R4 | 2096h | 2096h | LTE_CA_B2_B4_B5_B30-Perf | 34 | AT&T | AT&T | Rel-13 | 66 | RP-151131 |
| 4204 | 1537.51 | **LTE Advanced 4 Band Carrier Aggregation (4DL/1UL) of Band 2, Band 4, Band 29 and Band 30** | 262d? | 2014-12-15 A | 2015-12-15 A | 100% |  | R4 | 6288h | 6288h | LTE_CA_B2_B4_B29_B30 | 34 | AT&T | AT&T | Rel-13 | 66 |  |
| 4205 | 1537.51.1 | Core part:LTE Advanced 4 Band Carrier Aggregation (4DL/1UL) of Band 2, Band 4, Band 29 and Band 30 | 262d? | 2014-12-15 A | 2015-12-15 A | 100% | finish no earlier than 2015-12-15 | R4 | 2096h | 2096h | LTE_CA_B2_B4_B29_B30-Core | 34 | AT&T | AT&T | Rel-13 | 66 | RP-151131 |
| 4206 | 1537.51.2 | Perf. part:LTE Advanced 4 Band Carrier Aggregation (4DL/1UL) of Band 2, Band 4, Band 29 and Band 30 | 262d? | 2014-12-15 A | 2015-12-15 A | 100% | finish no earlier than 2015-12-15 | R4 | 2096h | 2096h | LTE_CA_B2_B4_B29_B30-Perf | 34 | AT&T | AT&T | Rel-13 | 66 | RP-151131 |
| 4207 | 1537.52 | **LTE Advanced 4 Band Carrier Aggregation (4DL/1UL) of Band 25, Band 41, Band 41 and Band 41** | 262d? | 2014-12-15 A | 2015-12-15 A | 100% |  | R4 | 6288h | 6288h | LTE_CA_B25_B41_B41_B41 | 34 | Alcatel-Lucent | Alcatel-Lucent | Rel-13 | 66 |  |
| 4208 | 1537.52.1 | Core part:LTE Advanced 4 Band Carrier Aggregation (4DL/1UL) of Band 25, Band 41, Band 41 and Band 41 | 262d? | 2014-12-15 A | 2015-12-15 A | 100% | finish no earlier than 2015-12-15 | R4 | 2096h | 2096h | LTE_CA_B25_B41_B41_B41-Core | 34 | Alcatel-Lucent | Alcatel-Lucent | Rel-13 | 66 | RP-151131 |
| 4209 | 1537.52.2 | Perf. part:LTE Advanced 4 Band Carrier Aggregation (4DL/1UL) of Band 25, Band 41, Band 41 and Band 41 | 262d? | 2014-12-15 A | 2015-12-15 A | 100% | finish no earlier than 2015-12-15 | R4 | 2096h | 2096h | LTE_CA_B25_B41_B41_B41-Perf | 34 | Alcatel-Lucent | Alcatel-Lucent | Rel-13 | 66 | RP-151131 |
| 4210 | 1537.53 | **LTE Advanced dual uplink inter-band Carrier Aggregation Class A1 in REL-13** | 262d? | 2014-12-15 A | 2015-12-15 A | 100% |  | R4 | 6288h | 6288h | LTE_CA_2UL_R13-A1 | 34 | Huawei | Huawei | Rel-13 | 66 |  |
| 4211 | 1537.53.1 | Core part:LTE Advanced dual uplink inter-band Carrier Aggregation Class A1 in REL-13 | 262d? | 2014-12-15 A | 2015-12-15 A | 100% | finish no earlier than 2015-12-15 | R4 | 2096h | 2096h | LTE_CA_2UL_R13-A1-Core | 34 | Huawei | Huawei | Rel-13 | 66 | RP-151131 |
| 4212 | 1537.53.2 | Perf. part:LTE Advanced dual uplink inter-band Carrier Aggregation Class A1 in REL-13 | 262d? | 2014-12-15 A | 2015-12-15 A | 100% | finish no earlier than 2015-12-15 | R4 | 2096h | 2096h | LTE_CA_2UL_R13-A1-Perf | 34 | Huawei | Huawei | Rel-13 | 66 | RP-151131 |

Notes:
- 4190: 1st Apr 15: Compl:0%->50% 1st Apr 15: WID: RP-142198->RP-150449 1st Apr 15: Stat Rep: ->RP-150013 03/07/15: Compl:50%->95% 03/07/15: Stat Rep: RP-150013->RP-150536 29/09/15: Stat Rep: RP-150536->RP-151131
- 4191: 1st Apr 15: Compl:0%->50% 1st Apr 15: WID: RP-142198->RP-150449 1st Apr 15: Stat Rep: ->RP-150013 03/07/15: Compl:50%->95% 03/07/15: Stat Rep: RP-150013->RP-150536 29/09/15: Stat Rep: RP-150536->RP-151131
- 4193: 1st Apr 15: Compl:0%->50% 1st Apr 15: CD:Tue 15/12/15->Tue 15/09/15 1st Apr 15: WID: RP-142199->RP-150448 1st Apr 15: Stat Rep: ->RP-150013 03/07/15: Compl:50%->95% 03/07/15: CD:Tue 15/09/15->Tue 15/12/15 03/07/15: Stat Rep: RP-150013->RP-150536 29/09
- 4194: 1st Apr 15: Compl:0%->50% 1st Apr 15: WID: RP-142199->RP-150448 1st Apr 15: Stat Rep: ->RP-150013 03/07/15: Compl:50%->95% 03/07/15: Stat Rep: RP-150013->RP-150536 29/09/15: Stat Rep: RP-150536->RP-151131
- 4196: 1st Apr 15: Compl:0%->50% 1st Apr 15: WID: RP-142200->RP-150450 1st Apr 15: Stat Rep: ->RP-150013 03/07/15: Compl:50%->95% 03/07/15: Stat Rep: RP-150013->RP-150536 29/09/15: Stat Rep: RP-150536->RP-151131
- 4197: 1st Apr 15: Compl:0%->50% 1st Apr 15: WID: RP-142200->RP-150450 1st Apr 15: Stat Rep: ->RP-150013 03/07/15: Compl:50%->95% 03/07/15: Stat Rep: RP-150013->RP-150536 29/09/15: Stat Rep: RP-150536->RP-151131
- 4199: 1st Apr 15: Compl:0%->50% 1st Apr 15: WID: RP-142201->RP-150452 1st Apr 15: Stat Rep: ->RP-150013 03/07/15: Compl:50%->95% 03/07/15: Stat Rep: RP-150013->RP-150536 29/09/15: Stat Rep: RP-150536->RP-151131
- 4200: 1st Apr 15: Compl:0%->50% 1st Apr 15: WID: RP-142201->RP-150452 1st Apr 15: Stat Rep: ->RP-150013 03/07/15: Compl:50%->95% 03/07/15: Stat Rep: RP-150013->RP-150536 29/09/15: Stat Rep: RP-150536->RP-151131
- 4202: 1st Apr 15: Compl:0%->50% 1st Apr 15: WID: RP-142202->RP-150451 1st Apr 15: Stat Rep: ->RP-150013 03/07/15: Compl:50%->95% 03/07/15: Stat Rep: RP-150013->RP-150536 29/09/15: Stat Rep: RP-150536->RP-151131
- 4203: 1st Apr 15: Compl:0%->50% 1st Apr 15: WID: RP-142202->RP-150451 1st Apr 15: Stat Rep: ->RP-150013 03/07/15: Compl:50%->95% 03/07/15: Stat Rep: RP-150013->RP-150536 29/09/15: Stat Rep: RP-150536->RP-151131
- 4205: 1st Apr 15: Compl:0%->50% 1st Apr 15: WID: RP-142203->RP-150453 1st Apr 15: Stat Rep: ->RP-150013 03/07/15: Compl:50%->95% 03/07/15: Stat Rep: RP-150013->RP-150536 29/09/15: Stat Rep: RP-150536->RP-151131
- 4206: 1st Apr 15: Compl:0%->50% 1st Apr 15: WID: RP-142203->RP-150453 1st Apr 15: Stat Rep: ->RP-150013 03/07/15: Compl:50%->95% 03/07/15: Stat Rep: RP-150013->RP-150536 29/09/15: Stat Rep: RP-150536->RP-151131
- 4208: 1st Apr 15: Compl:0%->50% 1st Apr 15: Stat Rep: ->RP-150013 03/07/15: Compl:50%->90% 03/07/15: Stat Rep: RP-150013->RP-150536 29/09/15: Compl:90%->95% 29/09/15: CD:Tue 15/09/15->Tue 15/12/15 29/09/15: Stat Rep: RP-150536->RP-151131
- 4209: 1st Apr 15: Compl:0%->25% 1st Apr 15: Stat Rep: ->RP-150013 03/07/15: Compl:25%->75% 03/07/15: Stat Rep: RP-150013->RP-150536 29/09/15: Compl:75%->80% 29/09/15: Stat Rep: RP-150536->RP-151131
- 4211: 1st Apr 15: Compl:0%->40% 1st Apr 15: WID: RP-141935->RP-150411 1st Apr 15: Stat Rep: ->RP-150013 03/07/15: Compl:40%->60% 03/07/15: WID: RP-150411->RP-150678 03/07/15: Stat Rep: RP-150013->RP-150536 29/09/15: Compl:60%->80% 29/09/15: Stat Rep: RP-150
- 4212: 1st Apr 15: Compl:0%->40% 1st Apr 15: WID: RP-141935->RP-150411 1st Apr 15: Stat Rep: ->RP-150013 03/07/15: Compl:40%->60% 03/07/15: WID: RP-150411->RP-150678 03/07/15: Stat Rep: RP-150013->RP-150536 29/09/15: Compl:60%->80% 29/09/15: Stat Rep: RP-150

| ID | WBS | Task | Duration | Start | Finish | Complete | Baseline start | Baseline finish | Baseline duration | Constraint | Resources | Work | Actual work | Acronym | PCG approved | WI rapporteur name | WI rapporteur e-mail | Release | TSG approved | Status Report | Acronym_3GU_Export |
| --- | --- | --- | --- | --- | --- | --- | --- | --- | --- | --- | --- | --- | --- | --- | --- | --- | --- | --- | --- | --- | --- |
| 4213 | 1537.54 | **LTE Advanced dual uplink inter-band Carrier Aggregation Class A2 in REL-13** | 262d? | 2014-12-15 A | 2015-12-15 A | 100% |  |  |  |  | R4 | 6288h | 6288h | LTE_CA_2UL_R13-A2 | 34 | Qualcomm | Qualcomm | Rel-13 | 66 |  |  |
| 4214 | 1537.54.1 | Core part:LTE Advanced dual uplink inter-band Carrier Aggregation Class A2 in REL-13 | 262d? | 2014-12-15 A | 2015-12-15 A | 100% |  |  |  | finish no earlier than 2015-12-15 | R4 | 2096h | 2096h | LTE_CA_2UL_R13-A2-Core | 34 | Qualcomm | Qualcomm | Rel-13 | 66 | RP-151131 |  |
| 4215 | 1537.54.2 | Perf. part:LTE Advanced dual uplink inter-band Carrier Aggregation Class A2 in REL-13 | 262d? | 2014-12-15 A | 2015-12-15 A | 100% |  |  |  | finish no earlier than 2015-12-15 | R4 | 2096h | 2096h | LTE_CA_2UL_R13-A2-Perf | 34 | Qualcomm | Qualcomm | Rel-13 | 66 | RP-151131 |  |
| 4216 | 1537.55 | **LTE Advanced dual uplink inter-band Carrier Aggregation Class A3 in REL-13** | 262d? | 2014-12-15 A | 2015-12-15 A | 100% |  |  |  |  | R4 | 6288h | 6288h | LTE_CA_2UL_R13-A3 | 34 | Ericsson | Ericsson | Rel-13 | 66 |  |  |
| 4217 | 1537.55.1 | Core part:LTE Advanced dual uplink inter-band Carrier Aggregation Class A3 in REL-13 | 262d? | 2014-12-15 A | 2015-12-15 A | 100% |  |  |  | finish no earlier than 2015-12-15 | R4 | 2096h | 2096h | LTE_CA_2UL_R13-A3-Core | 34 | Ericsson | Ericsson | Rel-13 | 66 | RP-151131 |  |
| 4218 | 1537.55.2 | Perf. part:LTE Advanced dual uplink inter-band Carrier Aggregation Class A3 in REL-13 | 262d? | 2014-12-15 A | 2015-12-15 A | 100% |  |  |  | finish no earlier than 2015-12-15 | R4 | 2096h | 2096h | LTE_CA_2UL_R13-A3-Perf | 34 | Ericsson | Ericsson | Rel-13 | 66 | RP-151131 |  |
| 4219 | 1537.56 | **LTE Advanced intra-band non-contiguous Carrier Aggregation in Band 41 for 4 DL** | 262d? | 2014-12-15 A | 2015-12-15 A | 100% |  |  |  |  | R4 | 6288h | 6288h | LTE_CA_NC_B41_4DL | 34 | Alcatel-Lucent | Alcatel-Lucent | Rel-13 | 66 |  |  |
| 4220 | 1537.56.1 | Core part:LTE Advanced intra-band non-contiguous Carrier Aggregation in Band 41 for 4 DL | 262d? | 2014-12-15 A | 2015-12-15 A | 100% |  |  |  | finish no earlier than 2015-12-15 | R4 | 2096h | 2096h | LTE_CA_NC_B41_4DL-Core | 34 | Alcatel-Lucent | Alcatel-Lucent | Rel-13 | 66 | RP-151131 |  |
| 4221 | 1537.56.2 | Perf. part:LTE Advanced intra-band non-contiguous Carrier Aggregation in Band 41 for 4 DL | 262d? | 2014-12-15 A | 2015-12-15 A | 100% | 2013-09-18 | 2015-12-24 | 593d? | finish no earlier than 2015-12-15 | R4 | 2096h | 2096h | LTE_CA_NC_B41_4DL-Perf | 31 | Alcatel-Lucent | Alcatel-Lucent | Rel-13 | 66 | RP-151131 | TEI13 |
| 4222 | 1537.57 | **LTE Advanced 3 Band Carrier Aggregation (3DL/1UL) of Band 1, Band 3 and Band 42** | 66d? | 2015-03-16 A | 2015-06-15 A | 100% |  |  |  |  | R4 | 1584h | 1584h | LTE_CA_B1_B3_B42 | 34 | NTT DOCOMO, INC. |  | Rel-13 | 67 |  |  |
| 4223 | 1537.57.1 | Core part:LTE Advanced 3 Band Carrier Aggregation (3DL/1UL) of Band 1, Band 3 and Band 42 | 66d? | 2015-03-16 A | 2015-06-15 A | 100% |  |  |  | finish no earlier than 2015-09-15 | R4 | 528h | 528h | LTE_CA_B1_B3_B42-Core | 34 | NTT DOCOMO, INC. |  | Rel-13 | 67 | RP-150536 |  |
| 4224 | 1537.57.2 | Perf. part:LTE Advanced 3 Band Carrier Aggregation (3DL/1UL) of Band 1, Band 3 and Band 42 | 66d? | 2015-03-16 A | 2015-06-15 A | 100% |  |  |  | finish no earlier than 2015-09-15 | R4 | 528h | 528h | LTE_CA_B1_B3_B42-Perf | 34 | NTT DOCOMO, INC. |  | Rel-13 | 67 | RP-150536 |  |
| 4225 | 1537.58 | **LTE Advanced 3 Band Carrier Aggregation (3DL/1UL) of Band 1, Band 19 and Band 42** | 66d? | 2015-03-16 A | 2015-06-15 A | 100% |  |  |  |  | R4 | 1584h | 1584h | LTE_CA_B1_B19_B42 | 34 | NTT DOCOMO, INC. |  | Rel-13 | 67 |  |  |
| 4226 | 1537.58.1 | Core part:LTE Advanced 3 Band Carrier Aggregation (3DL/1UL) of Band 1, Band 19 and Band 42 | 66d? | 2015-03-16 A | 2015-06-15 A | 100% |  |  |  | finish no earlier than 2015-09-15 | R4 | 528h | 528h | LTE_CA_B1_B19_B42-Core | 34 | NTT DOCOMO, INC. |  | Rel-13 | 67 | RP-150536 |  |
| 4227 | 1537.58.2 | Perf. part:LTE Advanced 3 Band Carrier Aggregation (3DL/1UL) of Band 1, Band 19 and Band 42 | 66d? | 2015-03-16 A | 2015-06-15 A | 100% |  |  |  | finish no earlier than 2015-09-15 | R4 | 528h | 528h | LTE_CA_B1_B19_B42-Perf | 34 | NTT DOCOMO, INC. |  | Rel-13 | 67 | RP-150536 |  |
| 4228 | 1537.59 | **LTE Advanced 3 Band Carrier Aggregation (3DL/1UL) of Band 1, Band 21 and Band 42** | 66d? | 2015-03-16 A | 2015-06-15 A | 100% |  |  |  |  | R4 | 1584h | 1584h | LTE_CA_B1_B21_B42 | 34 | NTT DOCOMO, INC. |  | Rel-13 | 67 |  |  |
| 4229 | 1537.59.1 | Core part:LTE Advanced 3 Band Carrier Aggregation (3DL/1UL) of Band 1, Band 21 and Band 42 | 66d? | 2015-03-16 A | 2015-06-15 A | 100% |  |  |  | finish no earlier than 2015-09-15 | R4 | 528h | 528h | LTE_CA_B1_B21_B42-Core | 34 | NTT DOCOMO, INC. |  | Rel-13 | 67 | RP-150536 |  |
| 4230 | 1537.59.2 | Perf. part:LTE Advanced 3 Band Carrier Aggregation (3DL/1UL) of Band 1, Band 21 and Band 42 | 66d? | 2015-03-16 A | 2015-06-15 A | 100% |  |  |  | finish no earlier than 2015-09-15 | R4 | 528h | 528h | LTE_CA_B1_B21_B42-Perf | 34 | NTT DOCOMO, INC. |  | Rel-13 | 67 | RP-150536 |  |
| 4231 | 1537.60 | **LTE Advanced 3 Band Carrier Aggregation (3DL/1UL) of Band 3, Band 19 and Band 42** | 66d? | 2015-03-16 A | 2015-06-15 A | 100% |  |  |  |  | R4 | 1584h | 1584h | LTE_CA_B3_B19_B42 | 34 | NTT DOCOMO, INC. |  | Rel-13 | 67 |  |  |
| 4232 | 1537.60.1 | Core part:LTE Advanced 3 Band Carrier Aggregation (3DL/1UL) of Band 3, Band 19 and Band 42 | 66d? | 2015-03-16 A | 2015-06-15 A | 100% |  |  |  | finish no earlier than 2015-09-15 | R4 | 528h | 528h | LTE_CA_B3_B19_B42-Core | 34 | NTT DOCOMO, INC. |  | Rel-13 | 67 | RP-150536 |  |
| 4233 | 1537.60.2 | Perf. part:LTE Advanced 3 Band Carrier Aggregation (3DL/1UL) of Band 3, Band 19 and Band 42 | 66d? | 2015-03-16 A | 2015-06-15 A | 100% |  |  |  | finish no earlier than 2015-09-15 | R4 | 528h | 528h | LTE_CA_B3_B19_B42-Perf | 34 | NTT DOCOMO, INC. |  | Rel-13 | 67 | RP-150536 |  |
| 4234 | 1537.61 | **LTE Advanced 3 Band Carrier Aggregation (3DL/1UL) of Band 19, Band 21 and Band 42** | 66d? | 2015-03-16 A | 2015-06-15 A | 100% |  |  |  |  | R4 | 1584h | 1584h | LTE_CA_B19_B21_B42 | 34 | NTT DOCOMO, INC. |  | Rel-13 | 67 |  |  |
| 4235 | 1537.61.1 | Core part:LTE Advanced 3 Band Carrier Aggregation (3DL/1UL) of Band 19, Band 21 and Band 42 | 66d? | 2015-03-16 A | 2015-06-15 A | 100% |  |  |  | finish no earlier than 2015-09-15 | R4 | 528h | 528h | LTE_CA_B19_B21_B42-Core | 34 | NTT DOCOMO, INC. |  | Rel-13 | 67 | RP-150536 |  |
| 4236 | 1537.61.2 | Perf. part:LTE Advanced 3 Band Carrier Aggregation (3DL/1UL) of Band 19, Band 21 and Band 42 | 66d? | 2015-03-16 A | 2015-06-15 A | 100% |  |  |  | finish no earlier than 2015-09-15 | R4 | 528h | 528h | LTE_CA_B19_B21_B42-Perf | 34 | NTT DOCOMO, INC. |  | Rel-13 | 67 | RP-150536 |  |

Notes:
- 4214: 1st Apr 15: Compl:0%->50% 1st Apr 15: WID: RP-141975->RP-150408 1st Apr 15: Stat Rep: ->RP-150013 03/07/15: Stat Rep: RP-150013->RP-150536 29/09/15: Stat Rep: RP-150536->RP-151131
- 4215: 1st Apr 15: Compl:0%->50% 1st Apr 15: WID: RP-141975->RP-150408 1st Apr 15: Stat Rep: ->RP-150013 03/07/15: Stat Rep: RP-150013->RP-150536 29/09/15: Stat Rep: RP-150536->RP-151131
- 4217: 1st Apr 15: Compl:0%->25% 1st Apr 15: WID: RP-142010->RP-150409 1st Apr 15: Stat Rep: ->RP-150013 03/07/15: Compl:25%->50% 03/07/15: Stat Rep: RP-150013->RP-150536 29/09/15: Compl:50%->75% 29/09/15: Stat Rep: RP-150536->RP-151131¦
- 4218: 1st Apr 15: Compl:0%->25% 1st Apr 15: WID: RP-142010->RP-150409 1st Apr 15: Stat Rep: ->RP-150013 03/07/15: Compl:25%->50% 03/07/15: Stat Rep: RP-150013->RP-150536 29/09/15: Compl:50%->75% 29/09/15: Stat Rep: RP-150536->RP-151131¦
- 4220: 1st Apr 15: Compl:0%->10% 1st Apr 15: CD:Tue 15/03/16->Tue 15/12/15 1st Apr 15: Stat Rep: ->RP-150013 03/07/15: Compl:10%->50% 03/07/15: Stat Rep: RP-150013->RP-150536 29/09/15: Compl:50%->80% 29/09/15: Stat Rep: RP-150536->RP-151131
- 4221: 1st Apr 15: Compl:0%->10% 1st Apr 15: CD:Tue 18/12/18->Tue 15/12/15 1st Apr 15: Stat Rep: -->RP-150013 03/07/15: Compl:10%->25% 03/07/15: Stat Rep: RP-150013->RP-150536 29/09/15: Compl:25%->50% 29/09/15: Stat Rep: RP-150536->RP-151131 ¦
- 4223: 03/07/15: Compl:0%->100% 03/07/15: CD:Tue 15/09/15->Mon 15/06/15 03/07/15: WID: RP-150121->RP-150641 03/07/15: Stat Rep: ->RP-150536
- 4224: 03/07/15: Compl:0%->100% 03/07/15: CD:Tue 15/09/15->Mon 15/06/15 03/07/15: WID: RP-150121->RP-150641 03/07/15: Stat Rep: ->RP-150536
- 4226: 03/07/15: Compl:0%->100% 03/07/15: CD:Tue 15/09/15->Mon 15/06/15 03/07/15: WID: RP-150122->RP-150642 03/07/15: Stat Rep: ->RP-150536
- 4227: 03/07/15: Compl:0%->100% 03/07/15: CD:Tue 15/09/15->Mon 15/06/15 03/07/15: WID: RP-150122->RP-150642 03/07/15: Stat Rep: ->RP-150536
- 4229: 03/07/15: Compl:0%->100% 03/07/15: CD:Tue 15/09/15->Mon 15/06/15 03/07/15: WID: RP-150123->RP-150643 03/07/15: Stat Rep: ->RP-150536
- 4230: 03/07/15: Compl:0%->100% 03/07/15: CD:Tue 15/09/15->Mon 15/06/15 03/07/15: WID: RP-150123->RP-150643 03/07/15: Stat Rep: ->RP-150536
- 4232: 03/07/15: Compl:0%->100% 03/07/15: CD:Tue 15/09/15->Mon 15/06/15 03/07/15: WID: RP-150124->RP-150644 03/07/15: Stat Rep: ->RP-150536
- 4233: 03/07/15: Compl:0%->100% 03/07/15: CD:Tue 15/09/15->Mon 15/06/15 03/07/15: WID: RP-150124->RP-150644 03/07/15: Stat Rep: ->RP-150536
- 4235: 03/07/15: Compl:0%->100% 03/07/15: CD:Tue 15/09/15->Mon 15/06/15 03/07/15: WID: RP-150125->RP-150645 03/07/15: Stat Rep: ->RP-150536
- 4236: 03/07/15: Compl:0%->100% 03/07/15: CD:Tue 15/09/15->Mon 15/06/15 03/07/15: WID: RP-150125->RP-150645 03/07/15: Stat Rep: ->RP-150536

| ID | WBS | Task | Duration | Start | Finish | Complete | Constraint | Resources | Work | Actual work | Acronym | PCG approved | WI rapporteur name | Release | TSG approved | Status Report |
| --- | --- | --- | --- | --- | --- | --- | --- | --- | --- | --- | --- | --- | --- | --- | --- | --- |
| 4237 | 1537.62 | **Additional bandwidth combination set for LTE Advanced 3 Band Carrier Aggregation (3DL/1UL) of Band 4, Band 4 and Band 7** | 197d? | 2015-03-16 A | 2015-12-15 A | 100% |  | R4 | 4728h | 4728h | LTE_CA_B4_B4_B7_BWset | 34 | Rogers Communications | Rel-13 | 67 |  |
| 4238 | 1537.62.1 | Core part: Additional bandwidth combination set for LTE Advanced 3 Band Carrier Aggregation (3DL/1UL) of Band 4, Band 4 and Band 7 | 197d? | 2015-03-16 A | 2015-12-15 A | 100% | finish no earlier than 2015-12-15 | R4 | 1576h | 1576h | LTE_CA_B4_B4_B7_BWset-Core | 34 | Rogers Communications | Rel-13 | 67 | RP-151131 |
| 4239 | 1537.62.2 | Perf. part: Additional bandwidth combination set for LTE Advanced 3 Band Carrier Aggregation (3DL/1UL) of Band 4, Band 4 and Band 7 | 197d? | 2015-03-16 A | 2015-12-15 A | 100% | finish no earlier than 2015-12-15 | R4 | 1576h | 1576h | LTE_CA_B4_B4_B7_BWset-Perf | 34 | Rogers Communications | Rel-13 | 67 | RP-151131 |
| 4240 | 1537.63 | **Additional bandwidth combination set for LTE Advanced 3 Band Carrier Aggregation (3DL/1UL) of Band 4, Band 7 and Band 12** | 197d? | 2015-03-16 A | 2015-12-15 A | 100% |  | R4 | 4728h | 4728h | LTE_CA_B4_B7_B12_BWset | 34 | Rogers Communications | Rel-13 | 67 |  |
| 4241 | 1537.63.1 | Core part: Additional bandwidth combination set for LTE Advanced 3 Band Carrier Aggregation (3DL/1UL) of Band 4, Band 7 and Band 12 | 197d? | 2015-03-16 A | 2015-12-15 A | 100% | finish no earlier than 2015-12-15 | R4 | 1576h | 1576h | LTE_CA_B4_B7_B12_BWset-Core | 34 | Rogers Communications | Rel-13 | 67 | RP-151131 |
| 4242 | 1537.63.2 | Perf. part: Additional bandwidth combination set for LTE Advanced 3 Band Carrier Aggregation (3DL/1UL) of Band 4, Band 7 and Band 12 | 197d? | 2015-03-16 A | 2015-12-15 A | 100% | finish no earlier than 2015-12-15 | R4 | 1576h | 1576h | LTE_CA_B4_B7_B12_BWset-Perf | 34 | Rogers Communications | Rel-13 | 67 | RP-151131 |
| 4243 | 1537.64 | **LTE Advanced 3 Band Carrier Aggregation (3DL/1UL) of Band 2, Band 7 and Band 12** | 262d? | 2015-03-16 A | 2016-03-15 A | 100% |  | R4 | 6288h | 6288h | LTE_CA_B2_B7_B12 | 34 | Rogers Communications | Rel-13 | 67 |  |
| 4244 | 1537.64.1 | Core part:LTE Advanced 3 Band Carrier Aggregation (3DL/1UL) of Band 2, Band 7 and Band 12 | 262d? | 2015-03-16 A | 2016-03-15 A | 100% | finish no earlier than 2016-03-15 | R4 | 2096h | 2096h | LTE_CA_B2_B7_B12-Core | 34 | Rogers Communications | Rel-13 | 67 | RP-151131 |
| 4245 | 1537.64.2 | Perf. part:LTE Advanced 3 Band Carrier Aggregation (3DL/1UL) of Band 2, Band 7 and Band 12 | 262d? | 2015-03-16 A | 2016-03-15 A | 100% | finish no earlier than 2016-03-15 | R4 | 2096h | 2096h | LTE_CA_B2_B7_B12-Perf | 34 | Rogers Communications | Rel-13 | 67 | RP-151131 |
| 4246 | 1537.65 | **LTE Advanced 3 Band Carrier Aggregation (3DL/1UL) of Band 2, Band 4 and Band 7** | 262d? | 2015-03-16 A | 2016-03-15 A | 100% |  | R4 | 6288h | 6288h | LTE_CA_B2_B4_B7 | 34 | Rogers Communications | Rel-13 | 67 |  |
| 4247 | 1537.65.1 | Core part:LTE Advanced 3 Band Carrier Aggregation (3DL/1UL) of Band 2, Band 4 and Band 7 | 262d? | 2015-03-16 A | 2016-03-15 A | 100% | finish no earlier than 2016-03-15 | R4 | 2096h | 2096h | LTE_CA_B2_B4_B7-Core | 34 | Rogers Communications | Rel-13 | 67 | RP-151131 |
| 4248 | 1537.65.2 | Perf. part:LTE Advanced 3 Band Carrier Aggregation (3DL/1UL) of Band 2, Band 4 and Band 7 | 262d? | 2015-03-16 A | 2016-03-15 A | 100% | finish no earlier than 2016-03-15 | R4 | 2096h | 2096h | LTE_CA_B2_B4_B7-Perf | 34 | Rogers Communications | Rel-13 | 67 | RP-151131 |
| 4249 | 1537.66 | **LTE Advanced 3 Band Carrier Aggregation (3DL/1UL) of Band 7, Band 20 and Band 38** | 197d? | 2015-03-16 A | 2015-12-15 A | 100% |  | R4 | 4728h | 4728h | LTE_CA_B7_B20_B38 | 34 | Nokia Networks | Rel-13 | 67 |  |
| 4250 | 1537.66.1 | Core part:LTE Advanced 3 Band Carrier Aggregation (3DL/1UL) of Band 7, Band 20 and Band 38 | 197d? | 2015-03-16 A | 2015-12-15 A | 100% | finish no earlier than 2015-12-15 | R4 | 1576h | 1576h | LTE_CA_B7_B20_B38-Core | 34 | Nokia Networks | Rel-13 | 67 | RP-151131 |
| 4251 | 1537.66.2 | Perf. part:LTE Advanced 3 Band Carrier Aggregation (3DL/1UL) of Band 7, Band 20 and Band 38 | 197d? | 2015-03-16 A | 2015-12-15 A | 100% | finish no earlier than 2015-12-15 | R4 | 1576h | 1576h | LTE_CA_B7_B20_B38-Perf | 34 | Nokia Networks | Rel-13 | 67 | RP-151131 |
| 4252 | 1537.67 | **LTE Advanced 4 Band Carrier Aggregation (4DL/1UL) of Band 2, Band 4, Band 4 and Band 12** | 197d? | 2015-03-16 A | 2015-12-15 A | 100% |  | R4 | 4728h | 4728h | LTE_CA_B2_B4_B4_B12 | 34 | Nokia Networks | Rel-13 | 67 |  |
| 4253 | 1537.67.1 | Core part:LTE Advanced 4 Band Carrier Aggregation (4DL/1UL) of Band 2, Band 4, Band 4 and Band 12 | 197d? | 2015-03-16 A | 2015-12-15 A | 100% | finish no earlier than 2015-12-15 | R4 | 1576h | 1576h | LTE_CA_B2_B4_B4_B12-Core | 34 | Nokia Networks | Rel-13 | 67 | RP-151131 |
| 4254 | 1537.67.2 | Perf. part:LTE Advanced 4 Band Carrier Aggregation (4DL/1UL) of Band 2, Band 4, Band 4 and Band 12 | 197d? | 2015-03-16 A | 2015-12-15 A | 100% | finish no earlier than 2015-12-15 | R4 | 1576h | 1576h | LTE_CA_B2_B4_B4_B12-Perf | 34 | Nokia Networks | Rel-13 | 67 | RP-151131 |
| 4255 | 1537.68 | **LTE Advanced 4 Band Carrier Aggregation (4DL/1UL) of Band 2, Band 2, Band 4 and Band 12** | 197d? | 2015-03-16 A | 2015-12-15 A | 100% |  | R4 | 4728h | 4728h | LTE_CA_B2_B2_B4_B12 | 34 | Nokia Networks | Rel-13 | 67 |  |
| 4256 | 1537.68.1 | Core part:LTE Advanced 4 Band Carrier Aggregation (4DL/1UL) of Band 2, Band 2, Band 4 and Band 12 | 197d? | 2015-03-16 A | 2015-12-15 A | 100% | finish no earlier than 2015-12-15 | R4 | 1576h | 1576h | LTE_CA_B2_B2_B4_B12-Core | 34 | Nokia Networks | Rel-13 | 67 | RP-151131 |
| 4257 | 1537.68.2 | Perf. part:LTE Advanced 4 Band Carrier Aggregation (4DL/1UL) of Band 2, Band 2, Band 4 and Band 12 | 197d? | 2015-03-16 A | 2015-12-15 A | 100% | finish no earlier than 2015-12-15 | R4 | 1576h | 1576h | LTE_CA_B2_B2_B4_B12-Perf | 34 | Nokia Networks | Rel-13 | 67 | RP-151131 |
| 4258 | 1537.69 | **LTE Advanced 4 Band Carrier Aggregation (4DL/1UL) of Band 2, Band 2, Band 4 and Band 4** | 197d? | 2015-03-16 A | 2015-12-15 A | 100% |  | R4 | 4728h | 4728h | LTE_CA_B2_B2_B4_B4 | 34 | Nokia Networks | Rel-13 | 67 |  |
| 4259 | 1537.69.1 | Core part:LTE Advanced 4 Band Carrier Aggregation (4DL/1UL) of Band 2, Band 2, Band 4 and Band 4 | 197d? | 2015-03-16 A | 2015-12-15 A | 100% | finish no earlier than 2015-12-15 | R4 | 1576h | 1576h | LTE_CA_B2_B2_B4_B4-Core | 34 | Nokia Networks | Rel-13 | 67 | RP-151131 |
| 4260 | 1537.69.2 | Perf. part:LTE Advanced 4 Band Carrier Aggregation (4DL/1UL) of Band 2, Band 2, Band 4 and Band 4 | 197d? | 2015-03-16 A | 2015-12-15 A | 100% | finish no earlier than 2015-12-15 | R4 | 1576h | 1576h | LTE_CA_B2_B2_B4_B4-Perf | 34 | Nokia Networks | Rel-13 | 67 | RP-151131 |

Notes:
- 4238: 03/07/15: CD:Tue 15/09/15->Tue 15/12/15 03/07/15: Stat Rep: ->RP-150536 29/09/15: Stat Rep: RP-150536->RP-151131
- 4239: 03/07/15: CD:Tue 15/09/15->Tue 15/12/15 03/07/15: Stat Rep: ->RP-150536 29/09/15: Stat Rep: RP-150536->RP-151131
- 4241: 03/07/15: CD:Tue 15/09/15->Tue 15/12/15 03/07/15: Stat Rep: ->RP-150536 29/09/15: Stat Rep: RP-150536->RP-151131
- 4242: 03/07/15: CD:Tue 15/09/15->Tue 15/12/15 03/07/15: Stat Rep: ->RP-150536 29/09/15: Stat Rep: RP-150536->RP-151131
- 4244: 03/07/15: Stat Rep: ->RP-150536 29/09/15: Stat Rep: RP-150536->RP-151131 ¦1/122/3/16: Compl:0%->100%
- 4245: 03/07/15: Stat Rep: ->RP-150536 29/09/15: Stat Rep: RP-150536->RP-151131 122/3/16: Compl:0%->100%
- 4247: 03/07/15: Stat Rep: ->RP-150536 29/09/15: Stat Rep: RP-150536->RP-1511311/1/16:22/3/16: Compl:0%->100%
- 4248: 03/07/15: Stat Rep: ->RP-150536 29/09/15: Stat Rep: RP-150536->RP-151131 1/1/1¦22/3/16: Compl:0%->100%
- 4250: 03/07/15: Compl:0%->30% 03/07/15: Stat Rep: ->RP-150536 29/09/15: Compl:30%->60% 29/09/15: Stat Rep: RP-150536->RP-151131
- 4251: 03/07/15: Compl:0%->30% 03/07/15: Stat Rep: ->RP-150536 29/09/15: Compl:30%->60% 29/09/15: Stat Rep: RP-150536->RP-151131
- 4253: 03/07/15: Compl:0%->95% 03/07/15: WID: RP-150073->RP-150660 03/07/15: Stat Rep: ->RP-150536 29/09/15: Stat Rep: RP-150536->RP-151131
- 4254: 03/07/15: Compl:0%->95% 03/07/15: WID: RP-150073->RP-150660 03/07/15: Stat Rep: ->RP-150536 29/09/15: Stat Rep: RP-150536->RP-151131
- 4256: 03/07/15: Compl:0%->95% 03/07/15: WID: RP-150074->RP-150659 03/07/15: Stat Rep: ->RP-150536 29/09/15: Stat Rep: RP-150536->RP-151131
- 4257: 03/07/15: Compl:0%->95% 03/07/15: WID: RP-150074->RP-150659 03/07/15: Stat Rep: ->RP-150536 29/09/15: Stat Rep: RP-150536->RP-151131
- 4259: 03/07/15: Compl:0%->95% 03/07/15: WID: RP-150075->RP-150658 03/07/15: Stat Rep: ->RP-150536 29/09/15: Stat Rep: RP-150536->RP-151131
- 4260: 03/07/15: Compl:0%->95% 03/07/15: WID: RP-150075->RP-150658 03/07/15: Stat Rep: ->RP-150536 29/09/15: Stat Rep: RP-150536->RP-151131

| ID | WBS | Task | Duration | Start | Finish | Complete | Constraint | Resources | Work | Actual work | Acronym | PCG approved | WI rapporteur name | Release | TSG approved | Status Report |
| --- | --- | --- | --- | --- | --- | --- | --- | --- | --- | --- | --- | --- | --- | --- | --- | --- |
| 4261 | 1537.70 | **LTE Advanced 4 Band Carrier Aggregation (4DL/1UL) of Band 1, Band 3, Band 5 and Band 40** | 197d? | 2015-03-16 A | 2015-12-15 A | 100% |  | R4 | 4728h | 4728h | LTE_CA_B1_B3_B5_B40 | 34 | SK Telecom | Rel-13 | 67 |  |
| 4262 | 1537.70.1 | Core part:LTE Advanced 4 Band Carrier Aggregation (4DL/1UL) of Band 1, Band 3, Band 5 and Band 40 | 197d? | 2015-03-16 A | 2015-12-15 A | 100% | finish no earlier than 2015-12-15 | R4 | 1576h | 1576h | LTE_CA_B1_B3_B5_B40-Core | 34 | SK Telecom | Rel-13 | 67 | RP-151131 |
| 4263 | 1537.70.2 | Perf. part:LTE Advanced 4 Band Carrier Aggregation (4DL/1UL) of Band 1, Band 3, Band 5 and Band 40 | 197d? | 2015-03-16 A | 2015-12-15 A | 100% | finish no earlier than 2015-12-15 | R4 | 1576h | 1576h | LTE_CA_B1_B3_B5_B40-Perf | 34 | SK Telecom | Rel-13 | 67 | RP-151131 |
| 4264 | 1537.71 | **LTE Advanced 4 Band Carrier Aggregation (4DL/1UL) of Band 1, Band 3, Band 7 and Band 8** | 197d? | 2015-03-16 A | 2015-12-15 A | 100% |  | R4 | 4728h | 4728h | LTE_CA_B1_B3_B7_B8 | 34 | Nokia Networks | Rel-13 | 67 |  |
| 4265 | 1537.71.1 | Core part:LTE Advanced 4 Band Carrier Aggregation (4DL/1UL) of Band 1, Band 3, Band 7 and Band 8 | 197d? | 2015-03-16 A | 2015-12-15 A | 100% | finish no earlier than 2015-12-15 | R4 | 1576h | 1576h | LTE_CA_B1_B3_B7_B8-Core | 34 | Nokia Networks | Rel-13 | 67 | RP-151131 |
| 4266 | 1537.71.2 | Perf. part:LTE Advanced 4 Band Carrier Aggregation (4DL/1UL) of Band 1, Band 3, Band 7 and Band 8 | 197d? | 2015-03-16 A | 2015-12-15 A | 100% | finish no earlier than 2015-12-15 | R4 | 1576h | 1576h | LTE_CA_B1_B3_B7_B8-Perf | 34 | Nokia Networks | Rel-13 | 67 | RP-151131 |
| 4267 | 1537.72 | **LTE Advanced 4 Band Carrier Aggregation (4DL/1UL) of Band 2, Band 4, Band 5 and Band 29** | 197d? | 2015-03-16 A | 2015-12-15 A | 100% |  | R4 | 4728h | 4728h | LTE_CA_B2_B4_B5_B29 | 34 | Huawei | Rel-13 | 67 |  |
| 4268 | 1537.72.1 | Core part:LTE Advanced 4 Band Carrier Aggregation (4DL/1UL) of Band 2, Band 4, Band 5 and Band 29 | 197d? | 2015-03-16 A | 2015-12-15 A | 100% | finish no earlier than 2015-12-15 | R4 | 1576h | 1576h | LTE_CA_B2_B4_B5_B29-Core | 34 | Huawei | Rel-13 | 67 | RP-151131 |
| 4269 | 1537.72.2 | Perf. part:LTE Advanced 4 Band Carrier Aggregation (4DL/1UL) of Band 2, Band 4, Band 5 and Band 29 | 197d? | 2015-03-16 A | 2015-12-15 A | 100% | finish no earlier than 2015-12-15 | R4 | 1576h | 1576h | LTE_CA_B2_B4_B5_B29-Perf | 34 | Huawei | Rel-13 | 67 | RP-151131 |
| 4270 | 1537.73 | **LTE Advanced dual uplink inter-band Carrier Aggregation FDD-TDD** | 197d? | 2015-03-16 A | 2015-12-15 A | 100% |  | R4 | 4728h | 4728h | LTE_CA_2UL_FDD_TDD | 34 | KDDI | Rel-13 | 67 |  |
| 4271 | 1537.73.1 | Core part:LTE Advanced dual uplink inter-band Carrier Aggregation FDD-TDD | 197d? | 2015-03-16 A | 2015-12-15 A | 100% | finish no earlier than 2015-12-15 | R4 | 1576h | 1576h | LTE_CA_2UL_FDD_TDD-Core | 34 | KDDI | Rel-13 | 67 | RP-151131 |
| 4272 | 1537.73.2 | Perf. part:LTE Advanced dual uplink inter-band Carrier Aggregation FDD-TDD | 197d? | 2015-03-16 A | 2015-12-15 A | 100% | finish no earlier than 2015-12-15 | R4 | 1576h | 1576h | LTE_CA_2UL_FDD_TDD-Perf | 34 | KDDI | Rel-13 | 67 | RP-151131 |
| 4273 | 1537.74 | **LTE Advanced dual uplink inter-band Carrier Aggregation Class A4** | 197d? | 2015-03-16 A | 2015-12-15 A | 100% |  | R4 | 4728h | 4728h | LTE_CA_2UL_R13-A4 | 34 | Nokia Networks | Rel-13 | 67 |  |
| 4274 | 1537.74.1 | Core part:LTE Advanced dual uplink inter-band Carrier Aggregation Class A4 in REL-13 | 197d? | 2015-03-16 A | 2015-12-15 A | 100% | finish no earlier than 2015-12-15 | R4 | 1576h | 1576h | LTE_CA_2UL_R13-A4-Core | 34 | Nokia Networks | Rel-13 | 67 | RP-151131 |
| 4275 | 1537.74.2 | Perf. Part:LTE Advanced dual uplink inter-band Carrier Aggregation Class A4 in REL-13 | 197d? | 2015-03-16 A | 2015-12-15 A | 100% | finish no earlier than 2015-12-15 | R4 | 1576h | 1576h | LTE_CA_2UL_R13-A4-Perf | 34 | Nokia Networks | Rel-13 | 67 | RP-151131 |
| 4276 | 1537.75 | **LTE Advanced 3DL/2UL inter-band Carrier Aggregation** | 197d? | 2015-03-16 A | 2015-12-15 A | 100% |  | R4 | 4728h | 4728h | LTE_CA_3DL_2UL | 34 | Nokia Corporation | Rel-13 | 67 |  |
| 4277 | 1537.75.1 | Core part:LTE Advanced 3DL/2UL inter-band Carrier Aggregation | 197d? | 2015-03-16 A | 2015-12-15 A | 100% | finish no earlier than 2015-12-15 | R4 | 1576h | 1576h | LTE_CA_3DL_2UL-Core | 34 | Nokia Corporation | Rel-13 | 67 | RP-151131 |
| 4278 | 1537.75.2 | Perf. part:LTE Advanced 3DL/2UL inter-band Carrier Aggregation | 197d? | 2015-03-16 A | 2015-12-15 A | 100% | finish no earlier than 2015-12-15 | R4 | 1576h | 1576h | LTE_CA_3DL_2UL-Perf | 34 | Nokia Corporation | Rel-13 | 67 | RP-151131 |
| 4279 | 1537.76 | **LTE Advanced intra-band non-contiguous Carrier Aggregation in Band 42 for 3DL** | 66d? | 2015-03-16 A | 2015-06-15 A | 100% |  | R4 | 1584h | 1584h | LTE_CA_NC_B42_3DL | 34 | Huawei | Rel-13 | 67 |  |
| 4280 | 1537.76.1 | Core part:LTE Advanced intra-band non-contiguous Carrier Aggregation in Band 42 for 3DL | 66d? | 2015-03-16 A | 2015-06-15 A | 100% | finish no earlier than 2015-09-15 | R4 | 528h | 528h | LTE_CA_NC_B42_3DL-Core | 34 | Huawei | Rel-13 | 67 | RP-150536 |
| 4281 | 1537.76.2 | Perf. part:LTE Advanced intra-band non-contiguous Carrier Aggregation in Band 42 for 3DL | 66d? | 2015-03-16 A | 2015-06-15 A | 100% | finish no earlier than 2015-09-15 | R4 | 528h | 528h | LTE_CA_NC_B42_3DL-Perf | 34 | Huawei | Rel-13 | 67 | RP-150536 |
| 4282 | 1537.77 | **LTE Advanced intra-band contiguous Carrier Aggregation in Band 8** | 197d? | 2015-03-16 A | 2015-12-15 A | 100% |  | R4 | 4728h | 4728h | LTE_CA_C_B8 | 34 | CMCC | Rel-13 | 67 |  |
| 4283 | 1537.77.1 | Core part: LTE Advanced intra-band contiguous Carrier Aggregation in Band 8 | 197d? | 2015-03-16 A | 2015-12-15 A | 100% | finish no earlier than 2015-12-15 | R4 | 1576h | 1576h | LTE_CA_C_B8-Core | 34 | CMCC | Rel-13 | 67 | RP-151131 |
| 4284 | 1537.77.2 | Perf. part: LTE Advanced intra-band contiguous Carrier Aggregation in Band 8 | 197d? | 2015-03-16 A | 2015-12-15 A | 100% | finish no earlier than 2015-12-15 | R4 | 1576h | 1576h | LTE_CA_C_B8-Perf | 34 | CMCC | Rel-13 | 67 | RP-151131 |

Notes:
- 4262: 03/07/15: Compl:0%->30% 03/07/15: WID: RP-150434->RP-150617 03/07/15: Stat Rep: ->RP-150536 29/09/15: Compl:30%->60% 29/09/15: CD:Tue 15/09/15->Tue 15/12/15 29/09/15: WID: RP-150617->RP-151216 29/09/15: Stat Rep: RP-150536->RP-151131
- 4263: 03/07/15: WID: RP-150434->RP-150617 03/07/15: Stat Rep: ->RP-150536 29/09/15: CD:Tue 15/09/15->Tue 15/12/15 29/09/15: WID: RP-150617->RP-151216 29/09/15: Stat Rep: RP-150536->RP-151131
- 4265: 03/07/15: Compl:0%->40% 03/07/15: Stat Rep: ->RP-150536 29/09/15: Compl:40%->45% 29/09/15: Stat Rep: RP-150536->RP-151131
- 4266: 03/07/15: Stat Rep: ->RP-150536 29/09/15: Stat Rep: RP-150536->RP-151131
- 4268: 03/07/15: Compl:0%->50% 03/07/15: Stat Rep: ->RP-150536 29/09/15: Compl:50%->95% 29/09/15: Stat Rep: RP-150536->RP-151131
- 4269: 03/07/15: Stat Rep: ->RP-150536 29/09/15: Compl:0%->95% 29/09/15: Stat Rep: RP-150536->RP-151131
- 4271: 03/07/15: Compl:0%->70% 03/07/15: Stat Rep: ->RP-150536 29/09/15: Compl:70%->90% 29/09/15: Stat Rep: RP-150536->RP-151131
- 4272: 03/07/15: CD:Tue 15/09/15->Tue 15/12/15 03/07/15: Stat Rep: ->RP-150536 29/09/15: Compl:0%->90% 29/09/15: Stat Rep: RP-150536->RP-151131
- 4274: 03/07/15: Compl:0%->25% 03/07/15: WID: RP-150410->RP-150616 03/07/15: Stat Rep: ->RP-150536 29/09/15: Compl:25%->75% 29/09/15: Stat Rep: RP-150536->RP-151131
- 4275: 03/07/15: Compl:0%->25% 03/07/15: WID: RP-150410->RP-150616 03/07/15: Stat Rep: ->RP-150536 29/09/15: Compl:25%->75% 29/09/15: Stat Rep: RP-150536->RP-151131
- 4277: 03/07/15: Compl:0%->25% 03/07/15: CD:Tue 15/03/16->Tue 15/12/15 03/07/15: Stat Rep: ->RP-150536 29/09/15: Compl:25%->75% 29/09/15: WID: RP-150479->RP-151230 29/09/15: Stat Rep: RP-150536->RP-151131
- 4278: 03/07/15: Compl:0%->25% 03/07/15: Stat Rep: ->RP-150536 29/09/15: Compl:25%->75% 29/09/15: CD:Tue 15/03/16->Tue 15/12/15 29/09/15: WID: RP-150479->RP-151230 29/09/15: Stat Rep: RP-150536->RP-151131
- 4280: 03/07/15: Compl:0%->100% 03/07/15: CD:Tue 15/09/15->Mon 15/06/15 03/07/15: Stat Rep: ->RP-150536
- 4281: 03/07/15: Compl:0%->100% 03/07/15: CD:Tue 15/09/15->Mon 15/06/15 03/07/15: Stat Rep: ->RP-150536
- 4283: 03/07/15: Compl:0%->60% 03/07/15: WID: RP-150437->RP-150809 03/07/15: Stat Rep: ->RP-150536 29/09/15: Compl:60%->90% 29/09/15: CD:Tue 15/09/15->Tue 15/12/15 29/09/15: WID: RP-150809->RP-151177 29/09/15: Stat Rep: RP-150536->RP-151131
- 4284: 03/07/15: WID: RP-150437->RP-150809 03/07/15: Stat Rep: ->RP-150536 29/09/15: Compl:0%->50% 29/09/15: CD:Tue 15/09/15->Tue 15/12/15 29/09/15: WID: RP-150809->RP-151177 29/09/15: Stat Rep: RP-150536->RP-151131¦

| ID | WBS | Task | Duration | Start | Finish | Complete | Remaining | Total slack | Constraint | Resources | Work | Actual work | Acronym | PCG approved | WI rapporteur name | Release | TSG approved | Status Report |
| --- | --- | --- | --- | --- | --- | --- | --- | --- | --- | --- | --- | --- | --- | --- | --- | --- | --- | --- |
| 4285 | 1537.78 | **LTE Advanced intra-band contiguous Carrier Aggregation in Band 42 for 4DL** | 197d? | 2015-03-16 A | 2015-12-15 A | 100% |  |  |  | R4 | 4728h | 4728h | LTE_CA_C_B42_4DL | 34 | CATT | Rel-13 | 67 |  |
| 4286 | 1537.78.1 | Core part: LTE Advanced intra-band contiguous Carrier Aggregation in Band 42 for 4DL | 197d? | 2015-03-16 A | 2015-12-15 A | 100% |  |  | finish no earlier than 2015-12-15 | R4 | 1576h | 1576h | LTE_CA_C_B42_4DL-Core | 34 | CATT | Rel-13 | 67 | RP-151131 |
| 4287 | 1537.78.2 | Perf. part: LTE Advanced intra-band contiguous Carrier Aggregation in Band 42 for 4DL | 197d? | 2015-03-16 A | 2015-12-15 A | 100% |  |  | finish no earlier than 2015-12-15 | R4 | 1576h | 1576h | LTE_CA_C_B42_4DL-Perf | 34 | CATT | Rel-13 | 67 | RP-151131 |
| 4288 | 1537.79 | **LTE Advanced 3 Band Carrier Aggregation (3DL/1UL) of Band 1, Band 8 and Band 11** | 67d? | 2015-06-15 A | 2015-09-15 A | 100% |  |  |  | R4 | 1608h | 1608h | LTE_CA_B1_B8_B11 | 35 | Softbank Mobile | Rel-13 | 68 |  |
| 4289 | 1537.79.1 | Core part:LTE Advanced 3 Band Carrier Aggregation (3DL/1UL) of Band 1, Band 8 and Band 11 | 67d? | 2015-06-15 A | 2015-09-15 A | 100% |  |  | finish no earlier than 2015-09-15 | R4 | 536h | 536h | LTE_CA_B1_B8_B11-Core | 35 | Softbank Mobile | Rel-13 | 68 | RP-151131 |
| 4290 | 1537.79.2 | Perf. part:LTE Advanced 3 Band Carrier Aggregation (3DL/1UL) of Band 1, Band 8 and Band 11 | 67d? | 2015-06-15 A | 2015-09-15 A | 100% |  |  | finish no earlier than 2015-09-15 | R4 | 536h | 536h | LTE_CA_B1_B8_B11-Perf | 35 | Softbank Mobile | Rel-13 | 68 | RP-151131 |
| 4291 | 1537.80 | **LTE Advanced 3 Band Carrier Aggregation (3DL/1UL) of Band 3, Band 20 and Band 32** | 197d? | 2015-06-15 A | 2016-03-15 | 90% | 19.69d? | 2605d |  | R4 | 4728h | 3364.8h | LTE_CA_B3_B20_B32 | 35 | Ericsson | Rel-13 | 68 |  |
| 4292 | 1537.80.1 | Core part:LTE Advanced 3 Band Carrier Aggregation (3DL/1UL) of Band 3, Band 20 and Band 32 | 197d? | 2015-06-15 A | 2016-03-15 | 90% | 19.7d? | 2605d | finish no earlier than 2016-03-15 | R4 | 1576h | 1418.4h | LTE_CA_B3_B20_B32-Core | 35 | Ericsson | Rel-14 | 68 | RP-151131 |
| 4293 | 1537.80.2 | Perf. part:LTE Advanced 3 Band Carrier Aggregation (3DL/1UL) of Band 3, Band 20 and Band 32 | 197d? | 2015-06-15 A | 2016-03-15 | 90% | 19.7d? | 2605d | finish no earlier than 2016-03-15 | R4 | 1576h | 1418.4h | LTE_CA_B3_B20_B32-Perf | 35 | Ericsson | Rel-14 | 68 | RP-151131 |
| 4294 | 1537.81 | **LTE Advanced 3 Band Carrier Aggregation (3DL/1UL) for Band 7, Band 42 and Band 42** | 132d? | 2015-06-15 A | 2015-12-15 A | 100% |  |  |  | R4 | 3168h | 3168h | LTE_CA_B7_B42_B42 | 35 | Huawei | Rel-13 | 68 |  |
| 4295 | 1537.81.1 | Core part:LTE Advanced 3 Band Carrier Aggregation (3DL/1UL) for Band 7, Band 42 and Band 42 | 132d? | 2015-06-15 A | 2015-12-15 A | 100% |  |  | finish no earlier than 2015-12-15 | R4 | 1056h | 1056h | LTE_CA_B7_B42_B42-Core | 35 | Huawei | Rel-13 | 68 | RP-151131 |
| 4296 | 1537.81.2 | Perf. part:LTE Advanced 3 Band Carrier Aggregation (3DL/1UL) for Band 7, Band 42 and Band 42 | 132d? | 2015-06-15 A | 2015-12-15 A | 100% |  |  | finish no earlier than 2015-12-15 | R4 | 1056h | 1056h | LTE_CA_B7_B42_B42-Perf | 35 | Huawei | Rel-13 | 68 | RP-151131 |
| 4297 | 1537.82 | **LTE Advanced 3 Band Carrier Aggregation (3DL/1UL) for Band 20, Band 42 and Band 42** | 67d? | 2015-06-15 A | 2015-09-15 A | 100% |  |  |  | R4 | 1608h | 1608h | LTE_CA_B20_B42_B42 | 35 | Huawei | Rel-13 | 68 |  |
| 4298 | 1537.82.1 | Core part:LTE Advanced 3 Band Carrier Aggregation (3DL/1UL) for Band 20, Band 42 and Band 42 | 67d? | 2015-06-15 A | 2015-09-15 A | 100% |  |  | finish no earlier than 2015-12-15 | R4 | 536h | 536h | LTE_CA_B20_B42_B42-Core | 35 | Huawei | Rel-13 | 68 | RP-151131 |
| 4299 | 1537.82.2 | Perf. part:LTE Advanced 3 Band Carrier Aggregation (3DL/1UL) for Band 20, Band 42 and Band 42 | 67d? | 2015-06-15 A | 2015-09-15 A | 100% |  |  | finish no earlier than 2015-12-15 | R4 | 536h | 536h | LTE_CA_B20_B42_B42-Perf | 35 | Huawei | Rel-13 | 68 | RP-151131 |
| 4300 | 1537.83 | **LTE Advanced 3 Band Carrier Aggregation (3DL/1UL) for Band 3, Band 7 and Band 38** | 132d? | 2015-06-15 A | 2015-12-15 A | 100% |  |  |  | R4 | 3168h | 3168h | LTE_CA_B3_B7_B38 | 35 | Nokia Networks | Rel-13 | 68 |  |
| 4301 | 1537.83.1 | Core part:LTE Advanced 3 Band Carrier Aggregation (3DL/1UL) for Band 3, Band 7 and Band 38 | 132d? | 2015-06-15 A | 2015-12-15 A | 100% |  |  | finish no earlier than 2015-12-15 | R4 | 1056h | 1056h | LTE_CA_B3_B7_B38-Core | 35 | Nokia Networks | Rel-13 | 68 | RP-151131 |
| 4302 | 1537.83.2 | Perf. part:LTE Advanced 3 Band Carrier Aggregation (3DL/1UL) for Band 3, Band 7 and Band 38 | 132d? | 2015-06-15 A | 2015-12-15 A | 100% |  |  | finish no earlier than 2015-12-15 | R4 | 1056h | 1056h | LTE_CA_B3_B7_B38-Perf | 35 | Nokia Networks | Rel-13 | 68 | RP-151131 |
| 4303 | 1537.84 | **LTE Advanced 3 Band Carrier Aggregation (3DL/1UL) of Band 28, Band 41 and Band 41** | 132d? | 2015-06-15 A | 2015-12-15 A | 100% |  |  |  | R4 | 3168h | 3168h | LTE_CA_B28_B41_B41 | 35 | KDDI | Rel-13 | 68 |  |
| 4304 | 1537.84.1 | Core part:LTE Advanced 3 Band Carrier Aggregation (3DL/1UL) of Band 28, Band 41 and Band 41 | 132d? | 2015-06-15 A | 2015-12-15 A | 100% |  |  | finish no earlier than 2015-12-15 | R4 | 1056h | 1056h | LTE_CA_B28_B41_B41-Core | 35 | KDDI | Rel-13 | 68 | RP-151131 |
| 4305 | 1537.84.2 | Perf. part:LTE Advanced 3 Band Carrier Aggregation (3DL/1UL) of Band 28, Band 41 and Band 41 | 132d? | 2015-06-15 A | 2015-12-15 A | 100% |  |  | finish no earlier than 2015-12-15 | R4 | 1056h | 1056h | LTE_CA_B28_B41_B41-Perf | 35 | KDDI | Rel-13 | 68 | RP-151131 |
| 4306 | 1537.85 | **LTE Advanced 3 Band Carrier Aggregation (3DL/1UL) of Band 28, Band 42 and Band 42** | 132d? | 2015-06-15 A | 2015-12-15 A | 100% |  |  |  | R4 | 3168h | 3168h | LTE_CA_B28_B42_B42 | 35 | KDDI | Rel-13 | 68 |  |
| 4307 | 1537.85.1 | Core part:LTE Advanced 3 Band Carrier Aggregation (3DL/1UL) of Band 28, Band 42 and Band 42 | 132d? | 2015-06-15 A | 2015-12-15 A | 100% |  |  | finish no earlier than 2015-12-15 | R4 | 1056h | 1056h | LTE_CA_B28_B42_B42-Core | 35 | KDDI | Rel-13 | 68 | RP-151131 |
| 4308 | 1537.85.2 | Perf. part:LTE Advanced 3 Band Carrier Aggregation (3DL/1UL) of Band 28, Band 42 and Band 42 | 132d? | 2015-06-15 A | 2015-12-15 A | 100% |  |  | finish no earlier than 2015-12-15 | R4 | 1056h | 1056h | LTE_CA_B28_B42_B42-Perf | 35 | KDDI | Rel-13 | 68 | RP-151131 |

Notes:
- 4286: 03/07/15: Compl:0%->50% 03/07/15: Stat Rep: ->RP-150536 29/09/15: Compl:50%->80% 29/09/15: Stat Rep: RP-150536->RP-151131
- 4287: 03/07/15: Compl:0%->50% 03/07/15: Stat Rep: ->RP-150536 29/09/15: Compl:50%->80% 29/09/15: Stat Rep: RP-150536->RP-151131
- 4289: 29/09/15: Compl:0%->100% 29/09/15: Stat Rep: -->RP-151131
- 4290: 29/09/15: Compl:0%->100% 29/09/15: Stat Rep: -->RP-151131
- 4292: 29/09/15: Compl:0%->50% 29/09/15: Stat Rep: -->RP-1511311/22/3/16: Compl:50%->90%
- 4293: 29/09/15: Compl:0%->50% 29/09/15: Stat Rep: -->RP-151131 ¦22/3/16: Compl:50%->90%
- 4295: 29/09/15: Compl:0%->70% 29/09/15: Stat Rep: -->RP-151131
- 4296: 29/09/15: Compl:0%->70% 29/09/15: Stat Rep: -->RP-151131
- 4298: 29/09/15: Compl:0%->100% 29/09/15: CD:Tue 15/12/15->Tue 15/09/15 29/09/15: Stat Rep: -->RP-151131
- 4299: 29/09/15: Compl:0%->100% 29/09/15: CD:Tue 15/12/15->Tue 15/09/15 29/09/15: Stat Rep: -->RP-151131
- 4301: 29/09/15: Compl:0%->60% 29/09/15: Stat Rep: -->RP-1511311/1/16: Compl:
- 4302: 29/09/15: Compl:0%->60% 29/09/15: Stat Rep: -->RP-151131¦1/1/16: Comp
- 4304: 29/09/15: Compl:0%->50% 29/09/15: Stat Rep: -->RP-151131
- 4305: 29/09/15: Stat Rep: -->RP-151131
- 4307: 29/09/15: Compl:0%->40% 29/09/15: WID: RP-151112->RP-151158 29/09/15: Stat Rep: -->RP-151131
- 4308: 29/09/15: WID: RP-151112->RP-151158 29/09/15: Stat Rep: -->RP-151131¦

| ID | WBS | Task | Duration | Start | Finish | Complete | Constraint | Resources | Work | Actual work | Acronym | PCG approved | WI rapporteur name | Release | TSG approved | Status Report |
| --- | --- | --- | --- | --- | --- | --- | --- | --- | --- | --- | --- | --- | --- | --- | --- | --- |
| 4309 | 1537.86 | **LTE Advanced 4 Band Carrier Aggregation (4DL/1UL) of Band 2, Band 4, Band 7 and Band 12** | 197d? | 2015-06-15 A | 2016-03-15 A | 100% |  | R4 | 4728h | 4728h | LTE_CA_B2_B4_B7_B12 | 35 | Rogers Communications | Rel-13 | 68 |  |
| 4310 | 1537.86.1 | Core part:LTE Advanced 4 Band Carrier Aggregation (4DL/1UL) of Band 2, Band 4, Band 7 and Band 12 | 197d? | 2015-06-15 A | 2016-03-15 A | 100% | finish no earlier than 2016-03-15 | R4 | 1576h | 1576h | LTE_CA_B2_B4_B7_B12-Core | 35 | Rogers Communications | Rel-13 | 68 | RP-151131 |
| 4311 | 1537.86.2 | Perf. part:LTE Advanced 4 Band Carrier Aggregation (4DL/1UL) of Band 2, Band 4, Band 7 and Band 12 | 197d? | 2015-06-15 A | 2016-03-15 A | 100% | finish no earlier than 2016-03-15 | R4 | 1576h | 1576h | LTE_CA_B2_B4_B7_B12-Perf | 35 | Rogers Communications | Rel-13 | 68 | RP-151131 |
| 4312 | 1537.87 | **LTE Advanced 4 Band Carrier Aggregation (4DL/1UL) of Band 1, Band 3, Band 19 and Band 42** | 132d? | 2015-06-15 A | 2015-12-15 A | 100% |  | R4 | 3168h | 3168h | LTE_CA_B1_B3_B19_B42 | 35 | NTT DOCOMO, INC. | Rel-13 | 68 |  |
| 4313 | 1537.87.1 | Core part:LTE Advanced 4 Band Carrier Aggregation (4DL/1UL) of Band 1, Band 3, Band 19 and Band 42 | 132d? | 2015-06-15 A | 2015-12-15 A | 100% | finish no earlier than 2015-12-15 | R4 | 1056h | 1056h | LTE_CA_B1_B3_B19_B42-Core | 35 | NTT DOCOMO, INC. | Rel-13 | 68 | RP-151131 |
| 4314 | 1537.87.2 | Perf. part:LTE Advanced 4 Band Carrier Aggregation (4DL/1UL) of Band 1, Band 3, Band 19 and Band 42 | 132d? | 2015-06-15 A | 2015-12-15 A | 100% | finish no earlier than 2015-12-15 | R4 | 1056h | 1056h | LTE_CA_B1_B3_B19_B42-Perf | 35 | NTT DOCOMO, INC. | Rel-13 | 68 | RP-151131 |
| 4315 | 1537.88 | **LTE Advanced 4 Band Carrier Aggregation (4DL/1UL) of Band 1, Band 3, Band 42 and Band 42** | 132d? | 2015-06-15 A | 2015-12-15 A | 100% |  | R4 | 3168h | 3168h | LTE_CA_B1_B3_B42_B42 | 35 | NTT DOCOMO, INC. | Rel-13 | 68 |  |
| 4316 | 1537.88.1 | Core part:LTE Advanced 4 Band Carrier Aggregation (4DL/1UL) of Band 1, Band 3, Band 42 and Band 42 | 132d? | 2015-06-15 A | 2015-12-15 A | 100% | finish no earlier than 2015-12-15 | R4 | 1056h | 1056h | LTE_CA_B1_B3_B42_B42-Core | 35 | NTT DOCOMO, INC. | Rel-13 | 68 | RP-151131 |
| 4317 | 1537.88.2 | Perf. part:LTE Advanced 4 Band Carrier Aggregation (4DL/1UL) of Band 1, Band 3, Band 42 and Band 42 | 132d? | 2015-06-15 A | 2015-12-15 A | 100% | finish no earlier than 2015-12-15 | R4 | 1056h | 1056h | LTE_CA_B1_B3_B42_B42-Perf | 35 | NTT DOCOMO, INC. | Rel-13 | 68 | RP-151131 |
| 4318 | 1537.89 | **LTE Advanced 4 Band Carrier Aggregation (4DL/1UL) of Band 1, Band 19, Band 42 and Band 42** | 132d? | 2015-06-15 A | 2015-12-15 A | 100% |  | R4 | 3168h | 3168h | LTE_CA_B1_B19_B42_B42 | 35 | NTT DOCOMO, INC. | Rel-13 | 68 |  |
| 4319 | 1537.89.1 | Core part:LTE Advanced 4 Band Carrier Aggregation (4DL/1UL) of Band 1, Band 19, Band 42 and Band 42 | 132d? | 2015-06-15 A | 2015-12-15 A | 100% | finish no earlier than 2015-12-15 | R4 | 1056h | 1056h | LTE_CA_B1_B19_B42_B42-Core | 35 | NTT DOCOMO, INC. | Rel-13 | 68 | RP-151131 |
| 4320 | 1537.89.2 | Perf. part:LTE Advanced 4 Band Carrier Aggregation (4DL/1UL) of Band 1, Band 19, Band 42 and Band 42 | 132d? | 2015-06-15 A | 2015-12-15 A | 100% | finish no earlier than 2015-12-15 | R4 | 1056h | 1056h | LTE_CA_B1_B19_B42_B42-Perf | 35 | NTT DOCOMO, INC. | Rel-13 | 68 | RP-151131 |
| 4321 | 1537.90 | **LTE Advanced 4 Band Carrier Aggregation (4DL/1UL) of Band 3, Band 19, Band 42 and Band 42** | 132d? | 2015-06-15 A | 2015-12-15 A | 100% |  | R4 | 3168h | 3168h | LTE_CA_B3_B19_B42_B42 | 35 | NTT DOCOMO, INC. | Rel-13 | 68 |  |
| 4322 | 1537.90.1 | Core part:LTE Advanced 4 Band Carrier Aggregation (4DL/1UL) of Band 3, Band 19, Band 42 and Band 42 | 132d? | 2015-06-15 A | 2015-12-15 A | 100% | finish no earlier than 2015-12-15 | R4 | 1056h | 1056h | LTE_CA_B3_B19_B42_B42-Core | 35 | NTT DOCOMO, INC. | Rel-13 | 68 | RP-151131 |
| 4323 | 1537.90.2 | Perf. part:LTE Advanced 4 Band Carrier Aggregation (4DL/1UL) of Band 3, Band 19, Band 42 and Band 42 | 132d? | 2015-06-15 A | 2015-12-15 A | 100% | finish no earlier than 2015-12-15 | R4 | 1056h | 1056h | LTE_CA_B3_B19_B42_B42-Perf | 35 | NTT DOCOMO, INC. | Rel-13 | 68 | RP-151131 |
| 4324 | 1537.91 | **LTE Advanced 4 Band Carrier Aggregation (4DL/1UL) of Band 1, Band 19, Band 21 and Band 42** | 132d? | 2015-06-15 A | 2015-12-15 A | 100% |  | R4 | 3168h | 3168h | LTE_CA_B1_B19_B21_B42 | 35 | NTT DOCOMO, INC. | Rel-13 | 68 |  |
| 4325 | 1537.91.1 | Core part:LTE Advanced 4 Band Carrier Aggregation (4DL/1UL) of Band 1, Band 19, Band 21 and Band 42 | 132d? | 2015-06-15 A | 2015-12-15 A | 100% | finish no earlier than 2015-12-15 | R4 | 1056h | 1056h | LTE_CA_B1_B19_B21_B42-Core | 35 | NTT DOCOMO, INC. | Rel-13 | 68 | RP-151131 |
| 4326 | 1537.91.2 | Perf. part:LTE Advanced 4 Band Carrier Aggregation (4DL/1UL) of Band 1, Band 19, Band 21 and Band 42 | 132d? | 2015-06-15 A | 2015-12-15 A | 100% | finish no earlier than 2015-12-15 | R4 | 1056h | 1056h | LTE_CA_B1_B19_B21_B42-Perf | 35 | NTT DOCOMO, INC. | Rel-13 | 68 | RP-151131 |
| 4327 | 1537.92 | **LTE Advanced 4 Band Carrier Aggregation (4DL/1UL) of Band 1, Band 21, Band 42 and Band 42** | 132d? | 2015-06-15 A | 2015-12-15 A | 100% |  | R4 | 3168h | 3168h | LTE_CA_B1_B21_B42_B42 | 35 | NTT DOCOMO, INC. | Rel-13 | 68 |  |
| 4328 | 1537.92.1 | Core part:LTE Advanced 4 Band Carrier Aggregation (4DL/1UL) of Band 1, Band 21, Band 42 and Band 42 | 132d? | 2015-06-15 A | 2015-12-15 A | 100% | finish no earlier than 2015-12-15 | R4 | 1056h | 1056h | LTE_CA_B1_B21_B42_B42-Core | 35 | NTT DOCOMO, INC. | Rel-13 | 68 | RP-151131 |
| 4329 | 1537.92.2 | Perf. part:LTE Advanced 4 Band Carrier Aggregation (4DL/1UL) of Band 1, Band 21, Band 42 and Band 42 | 132d? | 2015-06-15 A | 2015-12-15 A | 100% | finish no earlier than 2015-12-15 | R4 | 1056h | 1056h | LTE_CA_B1_B21_B42_B42-Perf | 35 | NTT DOCOMO, INC. | Rel-13 | 68 | RP-151131 |
| 4330 | 1537.93 | **LTE Advanced 4 Band Carrier Aggregation (4DL/1UL) of Band 19, Band 21, Band 42 and Band 42** | 132d? | 2015-06-15 A | 2015-12-15 A | 100% |  | R4 | 3168h | 3168h | LTE_CA_B19_B21_B42_B42 | 35 | NTT DOCOMO, INC. | Rel-13 | 68 |  |
| 4331 | 1537.93.1 | Core part:LTE Advanced 4 Band Carrier Aggregation (4DL/1UL) of Band 19, Band 21, Band 42 and Band 42 | 132d? | 2015-06-15 A | 2015-12-15 A | 100% | finish no earlier than 2015-12-15 | R4 | 1056h | 1056h | LTE_CA_B19_B21_B42_B42-Core | 35 | NTT DOCOMO, INC. | Rel-13 | 68 | RP-151131 |
| 4332 | 1537.93.2 | Perf. part:LTE Advanced 4 Band Carrier Aggregation (4DL/1UL) of Band 19, Band 21, Band 42 and Band 42 | 132d? | 2015-06-15 A | 2015-12-15 A | 100% | finish no earlier than 2015-12-15 | R4 | 1056h | 1056h | LTE_CA_B19_B21_B42_B42-Perf | 35 | NTT DOCOMO, INC. | Rel-13 | 68 | RP-151131 |

Notes:
- 4310: 29/09/15: Stat Rep: -->RP-151131 22/3/16: Compl:0%->100%
- 4311: 29/09/15: Stat Rep: -->RP-151131 ¦22/3/16: Compl:0%->100%
- 4313: 29/09/15: Compl:0%->95% 29/09/15: CD:Tue 15/09/15->Tue 15/12/15 29/09/15: Stat Rep: -->RP-151131
- 4314: 29/09/15: Compl:0%->95% 29/09/15: CD:Tue 15/09/15->Tue 15/12/15 29/09/15: Stat Rep: -->RP-151131
- 4316: 29/09/15: Compl:0%->95% 29/09/15: CD:Tue 15/09/15->Tue 15/12/15 29/09/15: Stat Rep: -->RP-151131
- 4317: 29/09/15: Compl:0%->95% 29/09/15: CD:Tue 15/09/15->Tue 15/12/15 29/09/15: Stat Rep: -->RP-151131
- 4319: 29/09/15: Compl:0%->95% 29/09/15: CD:Tue 15/09/15->Tue 15/12/15 29/09/15: Stat Rep: -->RP-151131
- 4320: 29/09/15: Compl:0%->95% 29/09/15: CD:Tue 15/09/15->Tue 15/12/15 29/09/15: Stat Rep: -->RP-151131
- 4322: 29/09/15: Compl:0%->95% 29/09/15: CD:Tue 15/09/15->Tue 15/12/15 29/09/15: Stat Rep: -->RP-151131
- 4323: 29/09/15: Compl:0%->95% 29/09/15: CD:Tue 15/09/15->Tue 15/12/15 29/09/15: Stat Rep: -->RP-151131
- 4325: 29/09/15: Compl:0%->95% 29/09/15: CD:Tue 15/09/15->Tue 15/12/15 29/09/15: Stat Rep: -->RP-151131
- 4326: 29/09/15: Compl:0%->95% 29/09/15: CD:Tue 15/09/15->Tue 15/12/15 29/09/15: Stat Rep: -->RP-151131
- 4328: 29/09/15: Compl:0%->95% 29/09/15: CD:Tue 15/09/15->Tue 15/12/15 29/09/15: Stat Rep: -->RP-151131
- 4329: 29/09/15: Compl:0%->95% 29/09/15: CD:Tue 15/09/15->Tue 15/12/15 29/09/15: Stat Rep: -->RP-151131
- 4331: 29/09/15: Compl:0%->95% 29/09/15: CD:Tue 15/09/15->Tue 15/12/15 29/09/15: Stat Rep: -->RP-151131
- 4332: 29/09/15: Compl:0%->95% 29/09/15: CD:Tue 15/09/15->Tue 15/12/15 29/09/15: Stat Rep: -->RP-151131

| ID | WBS | Task | Duration | Start | Finish | Complete | Constraint | Resources | Work | Actual work | Acronym | PCG approved | WI rapporteur name | Release | TSG approved | Status Report |
| --- | --- | --- | --- | --- | --- | --- | --- | --- | --- | --- | --- | --- | --- | --- | --- | --- |
| 4333 | 1537.94 | **LTE Advanced 4 Band Carrier Aggregation (4DL/1UL) of Band 2, Band 4, Band 5 and Band 12** | 132d? | 2015-06-15 A | 2015-12-15 A | 100% |  | R4 | 3168h | 3168h | LTE_CA_B2_B4_B5_B12 | 35 | U.S. Cellular | Rel-13 | 68 |  |
| 4334 | 1537.94.1 | Core part:LTE Advanced 4 Band Carrier Aggregation (4DL/1UL) of Band 2, Band 4, Band 5 and Band 12 | 132d? | 2015-06-15 A | 2015-12-15 A | 100% | finish no earlier than 2015-12-15 | R4 | 1056h | 1056h | LTE_CA_B2_B4_B5_B12-Core | 35 | U.S. Cellular | Rel-13 | 68 | RP-151131 |
| 4335 | 1537.94.2 | Perf. part:LTE Advanced 4 Band Carrier Aggregation (4DL/1UL) of Band 2, Band 4, Band 5 and Band 12 | 132d? | 2015-06-15 A | 2015-12-15 A | 100% | finish no earlier than 2015-12-15 | R4 | 1056h | 1056h | LTE_CA_B2_B4_B5_B12-Perf | 35 | U.S. Cellular | Rel-13 | 68 | RP-151131 |
| 4336 | 1537.95 | **LTE Advanced 4 Band Carrier Aggregation (4DL/1UL) of Band 2, Band 2, Band 4 and Band 5** | 132d? | 2015-06-15 A | 2015-12-15 A | 100% |  | R4 | 3168h | 3168h | LTE_CA_B2_B2_B4_B5 | 35 | U.S. Cellular | Rel-13 | 68 |  |
| 4337 | 1537.95.1 | Core part:LTE Advanced 4 Band Carrier Aggregation (4DL/1UL) of Band 2, Band 2, Band 4 and Band 5 | 132d? | 2015-06-15 A | 2015-12-15 A | 100% | finish no earlier than 2015-12-15 | R4 | 1056h | 1056h | LTE_CA_B2_B2_B4_B5-Core | 35 | U.S. Cellular | Rel-13 | 68 | RP-151131 |
| 4338 | 1537.95.2 | Perf. part:LTE Advanced 4 Band Carrier Aggregation (4DL/1UL) of Band 2, Band 2, Band 4 and Band 5 | 132d? | 2015-06-15 A | 2015-12-15 A | 100% | finish no earlier than 2015-12-15 | R4 | 1056h | 1056h | LTE_CA_B2_B2_B4_B5-Perf | 35 | U.S. Cellular | Rel-13 | 68 | RP-151131 |
| 4339 | 1537.96 | **LTE Advanced 4-Band Carrier Aggregation (4DL/1UL) of Band 2, Band 2, Band 12 and Band 12** | 132d? | 2015-06-15 A | 2015-12-15 A | 100% |  | R4 | 3168h | 3168h | LTE_CA_B2_B2_B12_B12 | 35 | U.S. Cellular | Rel-13 | 68 |  |
| 4340 | 1537.96.1 | Core part:LTE Advanced 4-Band Carrier Aggregation (4DL/1UL) of Band 2, Band 2, Band 12 and Band 12 | 132d? | 2015-06-15 A | 2015-12-15 A | 100% | finish no earlier than 2015-12-15 | R4 | 1056h | 1056h | LTE_CA_B2_B2_B12_B12-Core | 35 | U.S. Cellular | Rel-13 | 68 | RP-151131 |
| 4341 | 1537.96.2 | Perf. part:LTE Advanced 4-Band Carrier Aggregation (4DL/1UL) of Band 2, Band 2, Band 12 and Band 12 | 132d? | 2015-06-15 A | 2015-12-15 A | 100% | finish no earlier than 2015-12-15 | R4 | 1056h | 1056h | LTE_CA_B2_B2_B12_B12-Perf | 35 | U.S. Cellular | Rel-13 | 68 | RP-151131 |
| 4342 | 1537.97 | **LTE Advanced 4 Band Carrier Aggregation (4DL/1UL) of Band 4, Band 4, Band 5 and Band 30** | 197d? | 2015-06-15 A | 2016-03-15 A | 100% |  | R4 | 4728h | 4728h | LTE_CA_B4_B4_B5_B30 | 35 | AT&T | Rel-13 | 68 |  |
| 4343 | 1537.97.1 | Core part:LTE Advanced 4 Band Carrier Aggregation (4DL/1UL) of Band 4, Band 4, Band 5 and Band 30 | 197d? | 2015-06-15 A | 2016-03-15 A | 100% | finish no earlier than 2016-03-15 | R4 | 1576h | 1576h | LTE_CA_B4_B4_B5_B30-Core | 35 | AT&T | Rel-13 | 68 | RP-151131 |
| 4344 | 1537.97.2 | Perf. part:LTE Advanced 4 Band Carrier Aggregation (4DL/1UL) of Band 4, Band 4, Band 5 and Band 30 | 197d? | 2015-06-15 A | 2016-03-15 A | 100% | finish no earlier than 2016-03-15 | R4 | 1576h | 1576h | LTE_CA_B4_B4_B5_B30-Perf | 35 | AT&T | Rel-13 | 68 | RP-151131 |
| 4345 | 1537.98 | **LTE Advanced 4 Band Carrier Aggregation (4DL/1UL) of Band 4, Band 4, Band 12 and Band 30** | 197d? | 2015-06-15 A | 2016-03-15 A | 100% |  | R4 | 4728h | 4728h | LTE_CA_B4_B4_B12_B30 | 35 | AT&T | Rel-13 | 68 |  |
| 4346 | 1537.98.1 | Core part:LTE Advanced 4 Band Carrier Aggregation (4DL/1UL) of Band 4, Band 4, Band 12 and Band 30 | 197d? | 2015-06-15 A | 2016-03-15 A | 100% | finish no earlier than 2016-03-15 | R4 | 1576h | 1576h | LTE_CA_B4_B4_B12_B30-Core | 35 | AT&T | Rel-13 | 68 | RP-151131 |
| 4347 | 1537.98.2 | Perf. part:LTE Advanced 4 Band Carrier Aggregation (4DL/1UL) of Band 4, Band 4, Band 12 and Band 30 | 197d? | 2015-06-15 A | 2016-03-15 A | 100% | finish no earlier than 2016-03-15 | R4 | 1576h | 1576h | LTE_CA_B4_B4_B12_B30-Perf | 35 | AT&T | Rel-13 | 68 | RP-151131 |
| 4348 | 1537.99 | **LTE Advanced 4 Band Carrier Aggregation (4DL/1UL) of Band 4, Band 4, Band 29 and Band 30** | 197d? | 2015-06-15 A | 2016-03-15 A | 100% |  | R4 | 4728h | 4728h | LTE_CA_B4_B4_B29_B30 | 35 | AT&T | Rel-13 | 68 |  |
| 4349 | 1537.99.1 | Core part:LTE Advanced 4 Band Carrier Aggregation (4DL/1UL) of Band 4, Band 4, Band 29 and Band 30 | 197d? | 2015-06-15 A | 2016-03-15 A | 100% | finish no earlier than 2016-03-15 | R4 | 1576h | 1576h | LTE_CA_B4_B4_B29_B30-Core | 35 | AT&T | Rel-13 | 68 | RP-151131 |
| 4350 | 1537.99.2 | Perf. part:LTE Advanced 4 Band Carrier Aggregation (4DL/1UL) of Band 4, Band 4, Band 29 and Band 30 | 197d? | 2015-06-15 A | 2016-03-15 A | 100% | finish no earlier than 2016-03-15 | R4 | 1576h | 1576h | LTE_CA_B4_B4_B29_B30-Perf | 35 | AT&T | Rel-13 | 68 | RP-151131 |
| 4351 | 1537.100 | **LTE Advanced 4 Band Carrier Aggregation (4DL/1UL) of Band 2, Band 2, Band 5 and Band 12** | 132d? | 2015-06-15 A | 2015-12-15 A | 100% |  | R4 | 3168h | 3168h | LTE_CA_B2_B2_B5_B12 | 35 | U.S. Cellular | Rel-13 | 68 |  |
| 4352 | 1537.100.1 | Core part:LTE Advanced 4 Band Carrier Aggregation (4DL/1UL) of Band 2, Band 2, Band 5 and Band 12 | 132d? | 2015-06-15 A | 2015-12-15 A | 100% | finish no earlier than 2015-12-15 | R4 | 1056h | 1056h | LTE_CA_B2_B2_B5_B12-Core | 35 | U.S. Cellular | Rel-13 | 68 | RP-151131 |
| 4353 | 1537.100.2 | Perf. part:LTE Advanced 4 Band Carrier Aggregation (4DL/1UL) of Band 2, Band 2, Band 5 and Band 12 | 132d? | 2015-06-15 A | 2015-12-15 A | 100% | finish no earlier than 2015-12-15 | R4 | 1056h | 1056h | LTE_CA_B2_B2_B5_B12-Perf | 35 | U.S. Cellular | Rel-13 | 68 | RP-151131 |
| 4354 | 1537.101 | **LTE Advanced 4 Band Carrier Aggregation (4DL/1UL) of Band 2, Band 5, Band 12 and Band 12** | 132d? | 2015-06-15 A | 2015-12-15 A | 100% |  | R4 | 3168h | 3168h | LTE_CA_B2_B5_B12_B12 | 35 | U.S. Cellular | Rel-13 | 68 |  |
| 4355 | 1537.101.1 | Core part:LTE Advanced 4 Band Carrier Aggregation (4DL/1UL) of Band 2, Band 5, Band 12 and Band 12 | 132d? | 2015-06-15 A | 2015-12-15 A | 100% | finish no earlier than 2015-12-15 | R4 | 1056h | 1056h | LTE_CA_B2_B5_B12_B12-Core | 35 | U.S. Cellular | Rel-13 | 68 | RP-151131 |
| 4356 | 1537.101.2 | Perf. part:LTE Advanced 4 Band Carrier Aggregation (4DL/1UL) of Band 2, Band 5, Band 12 and Band 12 | 132d? | 2015-06-15 A | 2015-12-15 A | 100% | finish no earlier than 2015-12-15 | R4 | 1056h | 1056h | LTE_CA_B2_B5_B12_B12-Perf | 35 | U.S. Cellular | Rel-13 | 68 | RP-151131 |

Notes:
- 4334: 29/09/15: Compl:0%->40% 29/09/15: Stat Rep: -->RP-151131
- 4335: 29/09/15: Compl:0%->40% 29/09/15: Stat Rep: -->RP-151131
- 4337: 29/09/15: Compl:0%->40% 29/09/15: Stat Rep: -->RP-151131
- 4338: 29/09/15: Compl:0%->40% 29/09/15: Stat Rep: -->RP-151131
- 4340: 29/09/15: Compl:0%->40% 29/09/15: Stat Rep: -->RP-151131
- 4341: 29/09/15: Compl:0%->40% 29/09/15: Stat Rep: -->RP-151131
- 4343: 29/09/15: Stat Rep: -->RP-151131 22/3/16: Compl:50%->100%
- 4344: 29/09/15: Stat Rep: -->RP-151131 ¦22/3/16: Compl:50%->100%
- 4346: 29/09/15: Stat Rep: -->RP-151131 22/3/16: Compl:50%->100%
- 4347: 29/09/15: Stat Rep: -->RP-151131 22/3/16: Compl:50%->100%
- 4349: 29/09/15: Stat Rep: -->RP-151131 ¦22/3/16: Compl:50%->100%
- 4350: 29/09/15: Stat Rep: -->RP-151131 22/3/16: Compl:50%->100%
- 4352: 29/09/15: Compl:0%->40% 29/09/15: Stat Rep: -->RP-151131
- 4353: 29/09/15: Compl:0%->40% 29/09/15: Stat Rep: -->RP-151131
- 4355: 29/09/15: Compl:0%->40% 29/09/15: Stat Rep: -->RP-151131
- 4356: 29/09/15: Compl:0%->40% 29/09/15: Stat Rep: -->RP-151131

| ID | WBS | Task | Duration | Start | Finish | Complete | Constraint | Resources | Work | Actual work | Acronym | PCG approved | WI rapporteur name | Release | TSG approved | Status Report | Impacted TSs and TRs |
| --- | --- | --- | --- | --- | --- | --- | --- | --- | --- | --- | --- | --- | --- | --- | --- | --- | --- |
| 4357 | 1537.102 | **LTE Advanced 3DL/2UL mixed intra- and inter-band Carrier Aggregation** | 132d? | 2015-06-15 A | 2015-12-15 A | 100% |  | R4 | 3168h | 3168h | LTE_CA_3DL_2UL_inter_intra | 35 | Nokia Networks | Rel-14 | 68 |  |  |
| 4358 | 1537.102.1 | Core part:LTE Advanced 3DL/2UL mixed intra- and inter-band Carrier Aggregation | 132d? | 2015-06-15 A | 2015-12-15 A | 100% | finish no earlier than 2015-12-15 | R4 | 1056h | 1056h | LTE_CA_3DL_2UL_inter_intra-Core | 35 | Nokia Networks | Rel-13 | 68 | RP-151131 |  |
| 4359 | 1537.102.2 | Perf. part:LTE Advanced 3DL/2UL mixed intra- and inter-band Carrier Aggregation | 132d? | 2015-06-15 A | 2015-12-15 A | 100% | finish no earlier than 2015-12-15 | R4 | 1056h | 1056h | LTE_CA_3DL_2UL_inter_intra-Perf | 35 | Nokia Networks | Rel-13 | 68 | RP-151131 |  |
| 4360 | 1537.103 | **LTE Advanced intra-band contiguous Carrier Aggregation in Band 5** | 132d? | 2015-06-15 A | 2015-12-15 A | 100% |  | R4 | 3168h | 3168h | LTE_CA_C_B5 | 35 | Intel | Rel-13 | 68 |  |  |
| 4361 | 1537.103.1 | Core part: LTE Advanced intra-band contiguous Carrier Aggregation in Band 5 | 132d? | 2015-06-15 A | 2015-12-15 A | 100% | finish no earlier than 2015-12-15 | R4 | 1056h | 1056h | LTE_CA_C_B5-Core | 35 | Intel | Rel-13 | 68 | RP-151131 |  |
| 4362 | 1537.103.2 | Perf. part: LTE Advanced intra-band contiguous Carrier Aggregation in Band 5 | 132d? | 2015-06-15 A | 2015-12-15 A | 100% | finish no earlier than 2015-12-15 | R4 | 1056h | 1056h | LTE_CA_C_B5-Perf | 35 | Intel | Rel-13 | 68 | RP-151131 |  |
| 4363 | 1537.104 | **Additional bandwidth combination set for LTE Advanced intra-band non-contiguous Carrier Aggregation in Band 4** | 67d? | 2015-06-15 A | 2015-09-15 A | 100% |  | R4 | 1608h | 1608h | LTE_CA_NC_B4_BWset | 35 | Nokia Networks | Rel-13 | 68 |  |  |
| 4364 | 1537.104.1 | Core part: Additional bandwidth combination set for LTE Advanced intra-band non-contiguous Carrier Aggregation in Band 4 | 67d? | 2015-06-15 A | 2015-09-15 A | 100% | finish no earlier than 2015-09-15 | R4 | 536h | 536h | LTE_CA_NC_B4_BWset-Core | 35 | Nokia Networks | Rel-13 | 68 | RP-151131 |  |
| 4365 | 1537.104.2 | Perf. part: Additional bandwidth combination set for LTE Advanced intra-band non-contiguous Carrier Aggregation in Band 4 | 67d? | 2015-06-15 A | 2015-09-15 A | 100% | finish no earlier than 2015-09-15 | R4 | 536h | 536h | LTE_CA_NC_B4_BWset-Perf | 35 | Nokia Networks | Rel-13 | 68 | RP-151131 |  |
| 4366 | 1537.105 | **LTE Advanced intra-band non-contiguous Carrier Aggregation in Band 5** | 132d? | 2015-06-15 A | 2015-12-15 A | 100% |  | R4 | 3168h | 3168h | LTE_CA_NC_B5 | 35 | Intel | Rel-13 | 68 |  |  |
| 4367 | 1537.105.1 | Core part:LTE Advanced intra-band non-contiguous Carrier Aggregation in Band 5 | 132d? | 2015-06-15 A | 2015-12-15 A | 100% | finish no earlier than 2015-12-15 | R4 | 1056h | 1056h | LTE_CA_NC_B5-Core | 35 | Intel | Rel-13 | 68 | RP-151131 |  |
| 4368 | 1537.105.2 | Perf. part:LTE Advanced intra-band non-contiguous Carrier Aggregation in Band 5 | 132d? | 2015-06-15 A | 2015-12-15 A | 100% | finish no earlier than 2015-12-15 | R4 | 1056h | 1056h | LTE_CA_NC_B5-Perf | 35 | Intel | Rel-13 | 68 | RP-151131 |  |
| 4369 | 1537.106 | **LTE Advanced intra-band non-contiguous Carrier Aggregation in Band 42 for 4DL** | 132d? | 2015-06-15 A | 2015-12-15 A | 100% |  | R4 | 3168h | 3168h | LTE_CA_NC_B42_4DL | 35 | Huawei | Rel-13 | 68 |  |  |
| 4370 | 1537.106.1 | Core part:LTE Advanced intra-band non-contiguous Carrier Aggregation in Band 42 for 4DL | 132d? | 2015-06-15 A | 2015-12-15 A | 100% | finish no earlier than 2015-12-15 | R4 | 1056h | 1056h | LTE_CA_NC_B42_4DL-Core | 35 | Huawei | Rel-13 | 68 | RP-151131 |  |
| 4371 | 1537.106.2 | Perf. part:LTE Advanced intra-band non-contiguous Carrier Aggregation in Band 42 for 4DL | 132d? | 2015-06-15 A | 2015-12-15 A | 100% | finish no earlier than 2015-12-15 | R4 | 1056h | 1056h | LTE_CA_NC_B42_4DL-Perf | 35 | Huawei | Rel-13 | 68 | RP-151131 |  |
| 4372 | 1537.107 | **Additional bandwidth combination set for LTE Advanced inter-band Carrier Aggregation of Band 2 and Band 12** | 67d? | 2015-06-15 A | 2015-09-15 A | 100% |  | R4 | 1608h | 1608h | LTE_CA_B2_B12_BWset | 35 | Nokia Networks | Rel-13 | 68 |  |  |
| 4373 | 1537.107.1 | Core part: Additional bandwidth combination set for LTE Advanced inter-band Carrier Aggregation of Band 2 and Band 12 | 67d? | 2015-06-15 A | 2015-09-15 A | 100% | finish no earlier than 2015-09-15 | R4 | 536h | 536h | LTE_CA_B2_B12_BWset-Core | 35 | Nokia Networks | Rel-13 | 68 | RP-151131 |  |
| 4374 | 1537.107.2 | Perf. part: Additional bandwidth combination set for LTE Advanced inter-band Carrier Aggregation of Band 2 and Band 12 | 67d? | 2015-06-15 A | 2015-09-15 A | 100% | finish no earlier than 2015-09-15 | R4 | 536h | 536h | LTE_CA_B2_B12_BWset-Perf | 35 | Nokia Networks | Rel-13 | 68 | RP-151131 |  |
| 4375 | 1537.108 | **Additional bandwidth combination set 2 for LTE Advanced inter-band Carrier Aggregation of Band 4 and Band 12** | 67d? | 2015-06-15 A | 2015-09-15 A | 100% |  | R4 | 1608h | 1608h | LTE_CA_B4_B12_BWset2 | 35 | Nokia Networks | Rel-13 | 68 |  |  |
| 4376 | 1537.108.1 | Core part: Additional bandwidth combination set 2 for LTE Advanced inter-band Carrier Aggregation of Band 4 and Band 12 | 67d? | 2015-06-15 A | 2015-09-15 A | 100% | finish no earlier than 2015-09-15 | R4 | 536h | 536h | LTE_CA_B4_B12_BWset2-Core | 35 | Nokia Networks | Rel-13 | 68 | RP-151131 |  |
| 4377 | 1537.108.2 | Perf. part: Additional bandwidth combination set 2 for LTE Advanced inter-band Carrier Aggregation of Band 4 and Band 12 | 67d? | 2015-06-15 A | 2015-09-15 A | 100% | finish no earlier than 2015-09-15 | R4 | 536h | 536h | LTE_CA_B4_B12_BWset2-Perf | 35 | Nokia Networks | Rel-13 | 68 | RP-151131 |  |
| 4378 | 1537.109 | **Introduction of 1447-1467MHz Band for TD-LTE in China** | 330d? | 2015-06-15 A | 2016-09-15 A | 100% |  | R4 | 5824h | 5824h | LTE_TDD_1447MHz_China | 35 | Huawei | Rel-13 | 68 |  |  |
| 4379 | 1537.109.1 | Core part: Introduction of 1447-1467MHz Band for TD-LTE in China | 132d? | 2015-06-15 A | 2015-12-15 A | 100% | finish no earlier than 2015-12-15 | R4 | 1056h | 1056h | LTE_TDD_1447MHz_China-Core | 35 | Huawei | Rel-13 | 68 | RP-151242 | 36.892 |
| 4380 | 1537.109.2 | Perf. part: Introduction of 1447-1467MHz Band for TD-LTE in China | 132d? | 2015-06-15 A | 2015-12-15 A | 100% | finish no earlier than 2016-03-15 | R4 | 1056h | 1056h | LTE_TDD_1447MHz_China-Perf | 35 | Huawei | Rel-13 | 68 | RP-151242 |  |
| 4381 | 1537.109.3 | UE Conformance Test Aspects - Introduction of 1447-1467MHz Band for TD-LTE in China | 134d? | 2016-03-15 A | 2016-09-15 A | 100% | finish no earlier than 2016-09-15 | R5 | 1072h | 1072h | LTE_TDD_1447MHz_China-UEConTest | 36 | Huawei | Rel-13 | 71 |  |  |

Notes:
- 4357: covers combinations of contiguous intra-band CA and inter-band CA or combinations of non-contiguous intra-band CA and inter-band CA for LTE¦pure intra-band CA combinations are also covered by this WI¦note: There is already a REL-13 WI LTE_CA_3DL_2UL whi
- 4358: covers combinations of contiguous intra-band CA and inter-band CA or combinations of non-contiguous intra-band CA and inter-band CA for LTE¦pure intra-band CA combinations are also covered by this WI¦note: There is already a REL-13 WI LTE_CA_3DL_2UL
- 4359: covers combinations of contiguous intra-band CA and inter-band CA or combinations of non-contiguous intra-band CA and inter-band CA for LTE¦pure intra-band CA combinations are also covered by this WI¦note: There is already a REL-13 WI LTE_CA_3DL_2UL
- 4361: 29/09/15: Compl:0%->20% 29/09/15: Stat Rep: -->RP-151131
- 4362: 29/09/15: Compl:0%->20% 29/09/15: Stat Rep: -->RP-151131
- 4363: LTE_CA_NC_B4 was completed in REL-12
- 4364: LTE_CA_NC_B4 was completed in REL-12 29/09/15: Compl:0%->100% 29/09/15: Stat Rep: -->RP-151131
- 4365: LTE_CA_NC_B4 was completed in REL-12 29/09/15: Compl:0%->100% 29/09/15: Stat Rep: -->RP-151131
- 4367: 29/09/15: Compl:0%->20% 29/09/15: Stat Rep: -->RP-151131
- 4368: 29/09/15: Compl:0%->20% 29/09/15: Stat Rep: -->RP-151131
- 4370: 29/09/15: Compl:0%->50% 29/09/15: Stat Rep: -->RP-151131
- 4371: 29/09/15: Stat Rep: -->RP-151131
- 4372: LTE_CA_B2_B12 was completed as REL-12 WI
- 4373: LTE_CA_B2_B12 was completed as REL-12 WI 29/09/15: Compl:0%->100% 29/09/15: Stat Rep: -->RP-151131
- 4374: LTE_CA_B2_B12 was completed as REL-12 WI 29/09/15: Compl:0%->100% 29/09/15: Stat Rep: -->RP-151131
- 4375: LTE_CA_B4_B12 was completed in REL-11 and LTE_CA_B4_B12_BWset was completed in REL-12
- 4376: LTE_CA_B4_B12 was completed in REL-11 and LTE_CA_B4_B12_BWset was completed in REL-12 29/09/15: Compl:0%->100% 29/09/15: Stat Rep: -->RP-151131
- 4377: LTE_CA_B4_B12 was completed in REL-11 and LTE_CA_B4_B12_BWset was completed in REL-12 29/09/15: Compl:0%->100% 29/09/15: Stat Rep: -->RP-151131
- 4378: Aug 15: TR numb added
- 4379: Aug 15: TR numb added 29/09/15: Compl:0%->20% 29/09/15: Stat Rep: -->RP-151242
- 4380: 29/09/15: Stat Rep: -->RP-151242
- 4381: testing REL-13 LTE_TDD_1447MHz_China-Core¦1/7/16: C¦

| ID | WBS | Task | Duration | Start | Finish | Complete | Constraint | Resources | Work | Actual work | Acronym | PCG approved | WI rapporteur name | Release | TSG approved | Status Report |
| --- | --- | --- | --- | --- | --- | --- | --- | --- | --- | --- | --- | --- | --- | --- | --- | --- |
| 4382 | 1537.110 | **LTE Advanced 4 Band Carrier Aggregation (4DL/1UL) of Band 41, Band 41, Band 42 and Band 42** | 132d? | 2015-06-15 A | 2015-12-15 A | 100% |  | R4 | 3168h | 3168h | LTE_CA_B41_B41_B42_B42 | 35 | ZTE | Rel-13 | 68 |  |
| 4383 | 1537.110.1 | Core part:LTE Advanced 4 Band Carrier Aggregation (4DL/1UL) of Band 41, Band 41, Band 42 and Band 42 | 132d? | 2015-06-15 A | 2015-12-15 A | 100% | finish no earlier than 2015-12-15 | R4 | 1056h | 1056h | LTE_CA_B41_B41_B42_B42-Core | 35 | ZTE | Rel-13 | 68 | RP-151131 |
| 4384 | 1537.110.2 | Perf. part:LTE Advanced 4 Band Carrier Aggregation (4DL/1UL) of Band 41, Band 41, Band 42 and Band 42 | 132d? | 2015-06-15 A | 2015-12-15 A | 100% | finish no earlier than 2015-12-15 | R4 | 1056h | 1056h | LTE_CA_B41_B41_B42_B42-Perf | 35 | ZTE | Rel-13 | 68 | RP-151131 |
| 4385 | 1537.111 | **LTE Advanced inter-band Carrier Aggregation for Band 5 and Band 38** | 66d? | 2015-09-15 A | 2015-12-15 A | 100% |  | R4 | 1584h | 1584h | LTE_CA_B5_B38 | 35 | Huawei | Rel-13 | 69 |  |
| 4386 | 1537.111.1 | Core part:LTE Advanced inter-band Carrier Aggregation for Band 5 and Band 38 | 66d? | 2015-09-15 A | 2015-12-15 A | 100% | finish no earlier than 2015-12-15 | R4 | 528h | 528h | LTE_CA_B5_B38-Core | 35 | Huawei | Rel-13 | 69 |  |
| 4387 | 1537.111.2 | Perf. part:LTE Advanced inter-band Carrier Aggregation for Band 5 and Band 38 | 66d? | 2015-09-15 A | 2015-12-15 A | 100% | finish no earlier than 2015-12-15 | R4 | 528h | 528h | LTE_CA_B5_B38-Perf | 35 | Huawei | Rel-13 | 69 |  |
| 4388 | 1537.112 | **LTE Advanced 3 Band Carrier Aggregation (3DL/1UL) of Band 1, Band 11 and Band 18** | 66d? | 2015-09-15 A | 2015-12-15 A | 100% |  | R4 | 1584h | 1584h | LTE_CA_B1_B11_B18 | 35 | KDDI | Rel-13 | 69 |  |
| 4389 | 1537.112.1 | Core part:LTE Advanced 3 Band Carrier Aggregation (3DL/1UL) of Band 1, Band 11 and Band 18 | 66d? | 2015-09-15 A | 2015-12-15 A | 100% | finish no earlier than 2015-12-15 | R4 | 528h | 528h | LTE_CA_B1_B11_B18-Core | 35 | KDDI | Rel-13 | 69 |  |
| 4390 | 1537.112.2 | Perf. part:LTE Advanced 3 Band Carrier Aggregation (3DL/1UL) of Band 1, Band 11 and Band 18 | 66d? | 2015-09-15 A | 2015-12-15 A | 100% | finish no earlier than 2015-12-15 | R4 | 528h | 528h | LTE_CA_B1_B11_B18-Perf | 35 | KDDI | Rel-13 | 69 |  |
| 4391 | 1537.113 | **LTE Advanced 3 Band Carrier Aggregation (3DL/1UL) of Band 5, Band 40, and Band 40** | 66d? | 2015-09-15 A | 2015-12-15 A | 100% |  | R4 | 1584h | 1584h | LTE_CA_B5_B40_B40 | 35 | ZTE | Rel-13 | 69 |  |
| 4392 | 1537.113.1 | Core part:LTE Advanced 3 Band Carrier Aggregation (3DL/1UL) of Band 5, Band 40, and Band 40 | 66d? | 2015-09-15 A | 2015-12-15 A | 100% | finish no earlier than 2015-12-15 | R4 | 528h | 528h | LTE_CA_B5_B40_B40-Core | 35 | ZTE | Rel-13 | 69 |  |
| 4393 | 1537.113.2 | Perf. part:LTE Advanced 3 Band Carrier Aggregation (3DL/1UL) of Band 5, Band 40, and Band 40 | 66d? | 2015-09-15 A | 2015-12-15 A | 100% | finish no earlier than 2015-12-15 | R4 | 528h | 528h | LTE_CA_B5_B40_B40-Perf | 35 | ZTE | Rel-13 | 69 |  |
| 4394 | 1537.114 | **LTE Advanced 3 Band Carrier Aggregation (3DL/1UL) for Band 3, Band 41 and Band 42** | 66d? | 2015-09-15 A | 2015-12-15 A | 100% |  | R4 | 1584h | 1584h | LTE_CA_B3_B41_B42 | 35 | Huawei | Rel-13 | 69 |  |
| 4395 | 1537.114.1 | Core part:LTE Advanced 3 Band Carrier Aggregation (3DL/1UL) for Band 3, Band 41 and Band 42 | 66d? | 2015-09-15 A | 2015-12-15 A | 100% | finish no earlier than 2015-12-15 | R4 | 528h | 528h | LTE_CA_B3_B41_B42-Core | 35 | Huawei | Rel-13 | 69 |  |
| 4396 | 1537.114.2 | Perf. part:LTE Advanced 3 Band Carrier Aggregation (3DL/1UL) for Band 3, Band 41 and Band 42 | 66d? | 2015-09-15 A | 2015-12-15 A | 100% | finish no earlier than 2015-12-15 | R4 | 528h | 528h | LTE_CA_B3_B41_B42-Perf | 35 | Huawei | Rel-13 | 69 |  |
| 4397 | 1537.115 | **LTE Advanced 3 Band Carrier Aggregation (3DL/1UL) of Band 3, Band 41, and Band 41** | 66d? | 2015-09-15 A | 2015-12-15 A | 100% |  | R4 | 1584h | 1584h | LTE_CA_B3_B41_B41 | 35 | ZTE | Rel-13 | 69 |  |
| 4398 | 1537.115.1 | Core part:LTE Advanced 3 Band Carrier Aggregation (3DL/1UL) of Band 3, Band 41, and Band 41 | 66d? | 2015-09-15 A | 2015-12-15 A | 100% | finish no earlier than 2015-12-15 | R4 | 528h | 528h | LTE_CA_B3_B41_B41-Core | 35 | ZTE | Rel-13 | 69 |  |
| 4399 | 1537.115.2 | Perf. part:LTE Advanced 3 Band Carrier Aggregation (3DL/1UL) of Band 3, Band 41, and Band 41 | 66d? | 2015-09-15 A | 2015-12-15 A | 100% | finish no earlier than 2015-12-15 | R4 | 528h | 528h | LTE_CA_B3_B41_B41-Perf | 35 | ZTE | Rel-13 | 69 |  |
| 4400 | 1537.116 | **LTE Advanced 4 Band Carrier Aggregation (4DL1UL) of Band 39, Band 41, Band 41 and Band 41** | 66d? | 2015-09-15 A | 2015-12-15 A | 100% |  | R4 | 1584h | 1584h | LTE_CA_B39_B41_B41_B41 | 35 | CMCC | Rel-13 | 69 |  |
| 4401 | 1537.116.1 | Core part:LTE Advanced 4 Band Carrier Aggregation (4DL1UL) of Band 39, Band 41, Band 41 and Band 41 | 66d? | 2015-09-15 A | 2015-12-15 A | 100% | finish no earlier than 2015-12-15 | R4 | 528h | 528h | LTE_CA_B39_B41_B41_B41-Core | 35 | CMCC | Rel-13 | 69 |  |
| 4402 | 1537.116.2 | Perf. part:LTE Advanced 4 Band Carrier Aggregation (4DL1UL) of Band 39, Band 41, Band 41 and Band 41 | 66d? | 2015-09-15 A | 2015-12-15 A | 100% | finish no earlier than 2015-12-15 | R4 | 528h | 528h | LTE_CA_B39_B41_B41_B41-Perf | 35 | CMCC | Rel-13 | 69 |  |
| 4403 | 1537.117 | **LTE Advanced 4 Band Carrier Aggregation (4DL1UL) of Band 39, Band 39, Band 41 and Band 41** | 66d? | 2015-09-15 A | 2015-12-15 A | 100% |  | R4 | 1584h | 1584h | LTE_CA_B39_B39_B41_B41 | 35 | CMCC | Rel-13 | 69 |  |
| 4404 | 1537.117.1 | Core part:LTE Advanced 4 Band Carrier Aggregation (4DL1UL) of Band 39, Band 39, Band 41 and Band 41 | 66d? | 2015-09-15 A | 2015-12-15 A | 100% | finish no earlier than 2015-12-15 | R4 | 528h | 528h | LTE_CA_B39_B39_B41_B41-Core | 35 | CMCC | Rel-13 | 69 |  |
| 4405 | 1537.117.2 | Perf. part:LTE Advanced 4 Band Carrier Aggregation (4DL1UL) of Band 39, Band 39, Band 41 and Band 41 | 66d? | 2015-09-15 A | 2015-12-15 A | 100% | finish no earlier than 2015-12-15 | R4 | 528h | 528h | LTE_CA_B39_B39_B41_B41-Perf | 35 | CMCC | Rel-13 | 69 |  |

Notes:
- 4383: 29/09/15: Compl:0%->40% 29/09/15: WID: RP-150627->RP-151562 29/09/15: Stat Rep: ->RP-151131
- 4384: 29/09/15: Compl:0%->40% 29/09/15: WID: RP-150627->RP-151562 29/09/15: Stat Rep: ->RP-151131
- 4386: 1/1/16: Compl:0%->100%
- 4387: ¦1/1/16: Compl:0%->100%
- 4389: ¦1/1/16: Compl:0%->100%
- 4390: 1/1/16: Compl:0%->100%
- 4392: 1/1/16: Compl:0%->100%
- 4393: 1/1/16: Compl:0%->100%
- 4395: 1/1/16: Compl:0%->100%
- 4396: ¦1/1/16: Compl:0%->100%
- 4398: ¦1/1/16: Compl:0%->100%
- 4399: 1/1/16: Compl:0%->100%

| ID | WBS | Task | Duration | Start | Finish | Complete | Constraint | Resources | Work | Actual work | Acronym | PCG approved | WI rapporteur name | Release | TSG approved | Impacted TSs and TRs |
| --- | --- | --- | --- | --- | --- | --- | --- | --- | --- | --- | --- | --- | --- | --- | --- | --- |
| 4406 | 1537.118 | **LTE Advanced 4 Band Carrier Aggregation (4DL/1UL) of Band 1, Band 3, Band 8 and Band 40** | 66d? | 2015-09-15 A | 2015-12-15 A | 100% |  | R4 | 1584h | 1584h | LTE_CA_B1_B3_B8_B40 | 35 | KT | Rel-13 | 69 |  |
| 4407 | 1537.118.1 | Core part:LTE Advanced 4 Band Carrier Aggregation (4DL/1UL) of Band 1, Band 3, Band 8 and Band 40 | 66d? | 2015-09-15 A | 2015-12-15 A | 100% | finish no earlier than 2015-12-15 | R4 | 528h | 528h | LTE_CA_B1_B3_B8_B40-Core | 35 | KT | Rel-13 | 69 |  |
| 4408 | 1537.118.2 | Perf. part:LTE Advanced 4 Band Carrier Aggregation (4DL/1UL) of Band 1, Band 3, Band 8 and Band 40 | 66d? | 2015-09-15 A | 2015-12-15 A | 100% | finish no earlier than 2015-12-15 | R4 | 528h | 528h | LTE_CA_B1_B3_B8_B40-Perf | 35 | KT | Rel-13 | 69 |  |
| 4409 | 1537.119 | **LTE Advanced 4 Band Carrier Aggregation (4DL/1UL) for Band 3, Band 28, Band 40 and Band 40** | 66d? | 2015-09-15 A | 2015-12-15 A | 100% |  | R4 | 1584h | 1584h | LTE_CA_B3_B28_B40_B40 | 35 | Huawei | Rel-13 | 69 |  |
| 4410 | 1537.119.1 | Core part:LTE Advanced 4 Band Carrier Aggregation (4DL/1UL) for Band 3, Band 28, Band 40 and Band 40 | 66d? | 2015-09-15 A | 2015-12-15 A | 100% | finish no earlier than 2015-12-15 | R4 | 528h | 528h | LTE_CA_B3_B28_B40_B40-Core | 35 | Huawei | Rel-13 | 69 |  |
| 4411 | 1537.119.2 | Perf. part:LTE Advanced 4 Band Carrier Aggregation (4DL/1UL) for Band 3, Band 28, Band 40 and Band 40 | 66d? | 2015-09-15 A | 2015-12-15 A | 100% | finish no earlier than 2015-12-15 | R4 | 528h | 528h | LTE_CA_B3_B28_B40_B40-Perf | 35 | Huawei | Rel-13 | 69 |  |
| 4412 | 1537.120 | **LTE Advanced 4 Band Carrier Aggregation (4DL/1UL) for Band 28, Band 40, Band 40 and Band 40** | 66d? | 2015-09-15 A | 2015-12-15 A | 100% |  | R4 | 1584h | 1584h | LTE_CA_B28_B40_B40_B40 | 35 | Huawei | Rel-13 | 69 |  |
| 4413 | 1537.120.1 | Core part:LTE Advanced 4 Band Carrier Aggregation (4DL/1UL) for Band 28, Band 40, Band 40 and Band 40 | 66d? | 2015-09-15 A | 2015-12-15 A | 100% | finish no earlier than 2015-12-15 | R4 | 528h | 528h | LTE_CA_B28_B40_B40_B40-Core | 35 | Huawei | Rel-13 | 69 |  |
| 4414 | 1537.120.2 | Perf. part:LTE Advanced 4 Band Carrier Aggregation (4DL/1UL) for Band 28, Band 40, Band 40 and Band 40 | 66d? | 2015-09-15 A | 2015-12-15 A | 100% | finish no earlier than 2015-12-15 | R4 | 528h | 528h | LTE_CA_B28_B40_B40_B40-Perf | 35 | Huawei | Rel-13 | 69 |  |
| 4415 | 1537.121 | **LTE Advanced 4 Band Carrier Aggregation (4DL/1UL) of Band 3, Band 7, Band 7 and Band 28** | 66d? | 2015-09-15 A | 2015-12-15 A | 100% |  | R4 | 1584h | 1584h | LTE_CA_B3_B7_B7_B28 | 35 | Telstra | Rel-13 | 69 |  |
| 4416 | 1537.121.1 | Core part:LTE Advanced 4 Band Carrier Aggregation (4DL/1UL) of Band 3, Band 7, Band 7 and Band 28 | 66d? | 2015-09-15 A | 2015-12-15 A | 100% | finish no earlier than 2015-12-15 | R4 | 528h | 528h | LTE_CA_B3_B7_B7_B28-Core | 35 | Telstra | Rel-13 | 69 |  |
| 4417 | 1537.121.2 | Perf. part:LTE Advanced 4 Band Carrier Aggregation (4DL/1UL) of Band 3, Band 7, Band 7 and Band 28 | 66d? | 2015-09-15 A | 2015-12-15 A | 100% | finish no earlier than 2015-12-15 | R4 | 528h | 528h | LTE_CA_B3_B7_B7_B28-Perf | 35 | Telstra | Rel-13 | 69 |  |
| 4418 | 1537.122 | **LTE Advanced 5 Band Carrier Aggregation (5DL/1UL) of Band 1, Band 3, Band 19, Band 42 and Band 42** | 66d? | 2015-09-15 A | 2015-12-15 A | 100% |  | R4 | 1584h | 1584h | LTE_CA_B1_B3_B19_B42_B42 | 35 | NTT DOCOMO | Rel-13 | 69 | 36.857-13 |
| 4419 | 1537.122.1 | Core part:LTE Advanced 5 Band Carrier Aggregation (5DL/1UL) of Band 1, Band 3, Band 19, Band 42 and Band 42 | 66d? | 2015-09-15 A | 2015-12-15 A | 100% | finish no earlier than 2015-12-15 | R4 | 528h | 528h | LTE_CA_B1_B3_B19_B42_B42-Core | 35 | NTT DOCOMO | Rel-13 | 69 | 36.857-13 |
| 4420 | 1537.122.2 | Perf. part:LTE Advanced 5 Band Carrier Aggregation (5DL/1UL) of Band 1, Band 3, Band 19, Band 42 and Band 42 | 66d? | 2015-09-15 A | 2015-12-15 A | 100% | finish no earlier than 2015-12-15 | R4 | 528h | 528h | LTE_CA_B1_B3_B19_B42_B42-Perf | 35 | NTT DOCOMO | Rel-13 | 69 | 36.857-13 |
| 4421 | 1537.123 | **LTE Advanced 5 Band Carrier Aggregation (5DL/1UL) of Band 1, Band 19, Band 21, Band 42 and Band 42** | 66d? | 2015-09-15 A | 2015-12-15 A | 100% |  | R4 | 1584h | 1584h | LTE_CA_B1_B19_B21_B42_B42 | 35 | NTT DOCOMO | Rel-13 | 69 |  |
| 4422 | 1537.123.1 | Core part:LTE Advanced 5 Band Carrier Aggregation (5DL/1UL) of Band 1, Band 19, Band 21, Band 42 and Band 42 | 66d? | 2015-09-15 A | 2015-12-15 A | 100% | finish no earlier than 2015-12-15 | R4 | 528h | 528h | LTE_CA_B1_B19_B21_B42_B42-Core | 35 | NTT DOCOMO | Rel-13 | 69 |  |
| 4423 | 1537.123.2 | Perf. part:LTE Advanced 5 Band Carrier Aggregation (5DL/1UL) of Band 1, Band 19, Band 21, Band 42 and Band 42 | 66d? | 2015-09-15 A | 2015-12-15 A | 100% | finish no earlier than 2015-12-15 | R4 | 528h | 528h | LTE_CA_B1_B19_B21_B42_B42-Perf | 35 | NTT DOCOMO | Rel-13 | 69 |  |
| 4424 | 1537.124 | **LTE Advanced 5 Band Carrier Aggregation (5DL/1UL) of Band 1, Band 3, Band 7, Band 7 and Band 28** | 131d? | 2015-09-15 A | 2016-03-15 A | 100% |  | R4 | 3144h | 3144h | LTE_CA_B1_B3_B7_B7_B28 | 35 | Telstra | Rel-13 | 69 |  |
| 4425 | 1537.124.1 | Core part:LTE Advanced 5 Band Carrier Aggregation (5DL/1UL) of Band 1, Band 3, Band 7, Band 7 and Band 28 | 131d? | 2015-09-15 A | 2016-03-15 A | 100% | finish no earlier than 2016-03-15 | R4 | 1048h | 1048h | LTE_CA_B1_B3_B7_B7_B28-Core | 35 | Telstra | Rel-13 | 69 |  |
| 4426 | 1537.124.2 | Perf. part:LTE Advanced 5 Band Carrier Aggregation (5DL/1UL) of Band 1, Band 3, Band 7, Band 7 and Band 28 | 131d? | 2015-09-15 A | 2016-03-15 A | 100% | finish no earlier than 2016-03-15 | R4 | 1048h | 1048h | LTE_CA_B1_B3_B7_B7_B28-Perf | 35 | Telstra | Rel-13 | 69 |  |
| 4427 | 1537.125 | **LTE Advanced 5 Band Carrier Aggregation (5DL/1UL) of Band 3, Band 3, Band 7, Band 7 and Band 28** | 131d? | 2015-09-15 A | 2016-03-15 A | 100% |  | R4 | 3144h | 3144h | LTE_CA_B3_B3_B7_B7_B28 | 35 | Telstra | Rel-13 | 69 |  |
| 4428 | 1537.125.1 | Core part:LTE Advanced 5 Band Carrier Aggregation (5DL/1UL) of Band 3, Band 3, Band 7, Band 7 and Band 28 | 131d? | 2015-09-15 A | 2016-03-15 A | 100% | finish no earlier than 2016-03-15 | R4 | 1048h | 1048h | LTE_CA_B3_B3_B7_B7_B28-Core | 35 | Telstra | Rel-13 | 69 |  |
| 4429 | 1537.125.2 | Perf. part:LTE Advanced 5 Band Carrier Aggregation (5DL/1UL) of Band 3, Band 3, Band 7, Band 7 and Band 28 | 131d? | 2015-09-15 A | 2016-03-15 A | 100% | finish no earlier than 2016-03-15 | R4 | 1048h | 1048h | LTE_CA_B3_B3_B7_B7_B28-Perf | 35 | Telstra | Rel-13 | 69 |  |

Notes:
- 4407: ¦1/1
- 4408: 1
- 4425: ¦22/3/16: Compl:95%->100%;
- 4426: 22/3/16: Compl:95%->100%;
- 4428: 22/3/16: Compl:95%->100%
- 4429: ¦22/3/16: Compl:95%->100%

| ID | WBS | Task | Duration | Start | Finish | Complete | Baseline start | Baseline finish | Baseline duration | Constraint | Resources | Work | Actual work | Acronym | PCG approved | WI rapporteur name | Release | TSG approved | Impacted TSs and TRs | Status Report | WI rapporteur e-mail | Acronym_3GU_Export | Special Focus Doc | MCC resp |
| --- | --- | --- | --- | --- | --- | --- | --- | --- | --- | --- | --- | --- | --- | --- | --- | --- | --- | --- | --- | --- | --- | --- | --- | --- |
| 4430 | 1537.126 | **LTE Advanced 3 Band Carrier Aggregation (3DL/3UL) of Band 39, Band 41 and Band 41** | 66d? | 2015-09-15 A | 2015-12-15 A | 100% |  |  |  |  | R4 | 1584h | 1584h | LTE_CA_3DL3UL_B39_B41_B41 | 35 | CATT | Rel-13 | 69 |  |  |  |  |  |  |
| 4431 | 1537.126.1 | Core part:LTE Advanced 3 Band Carrier Aggregation (3DL/3UL) of Band 39, Band 41 and Band 41 | 66d? | 2015-09-15 A | 2015-12-15 A | 100% |  |  |  | finish no earlier than 2015-12-15 | R4 | 528h | 528h | LTE_CA_3DL3UL_B39_B41_B41-Core | 35 | CATT | Rel-13 | 69 |  |  |  |  |  |  |
| 4432 | 1537.126.2 | Perf. part:LTE Advanced 3 Band Carrier Aggregation (3DL/3UL) of Band 39, Band 41 and Band 41 | 66d? | 2015-09-15 A | 2015-12-15 A | 100% |  |  |  | finish no earlier than 2015-12-15 | R4 | 528h | 528h | LTE_CA_3DL3UL_B39_B41_B41-Perf | 35 | CATT | Rel-13 | 69 |  |  |  |  |  |  |
| 4433 | 1537.127 | **LTE Advanced 3 Band Carrier Aggregation (3DL/3UL) of Band 39, Band 39 and Band 41** | 66d? | 2015-09-15 A | 2015-12-15 A | 100% |  |  |  |  | R4 | 1584h | 1584h | LTE_CA_3DL3UL_B39_B39_B41 | 35 | CATT | Rel-13 | 69 | 36.899-13 |  |  |  |  |  |
| 4434 | 1537.127.1 | Core part:LTE Advanced 3 Band Carrier Aggregation (3DL/3UL) of Band 39, Band 39 and Band 41 | 66d? | 2015-09-15 A | 2015-12-15 A | 100% |  |  |  | finish no earlier than 2015-12-15 | R4 | 528h | 528h | LTE_CA_3DL3UL_B39_B39_B41-Core | 35 | CATT | Rel-13 | 69 |  |  |  |  |  |  |
| 4435 | 1537.127.2 | Perf. part:LTE Advanced 3 Band Carrier Aggregation (3DL/3UL) of Band 39, Band 39 and Band 41 | 66d? | 2015-09-15 A | 2015-12-15 A | 100% |  |  |  | finish no earlier than 2015-12-15 | R4 | 528h | 528h | LTE_CA_3DL3UL_B39_B39_B41-Perf | 35 | CATT | Rel-13 | 69 |  |  |  |  |  |  |
| 4436 | 1537.128 | **Additional bandwidth combination set for LTE Advanced intra-band non-contiguous Carrier Aggregation in Band 7** | 66d? | 2015-09-15 A | 2015-12-15 A | 100% |  |  |  |  | R4 | 1584h | 1584h | LTE_CA_NC_B7_BWset | 35 | Huawei | Rel-13 | 69 |  |  |  |  |  |  |
| 4437 | 1537.128.1 | Core part: Additional bandwidth combination set for LTE Advanced intra-band non-contiguous Carrier Aggregation in Band 7 | 66d? | 2015-09-15 A | 2015-12-15 A | 100% |  |  |  | finish no earlier than 2015-12-15 | R4 | 528h | 528h | LTE_CA_NC_B7_BWset-Core | 35 | Huawei | Rel-13 | 69 |  |  |  |  |  |  |
| 4438 | 1537.128.2 | Perf. part: Additional bandwidth combination set for LTE Advanced intra-band non-contiguous Carrier Aggregation in Band 7 | 66d? | 2015-09-15 A | 2015-12-15 A | 100% |  |  |  | finish no earlier than 2015-12-15 | R4 | 528h | 528h | LTE_CA_NC_B7_BWset-Perf | 35 | Huawei | Rel-13 | 69 |  |  |  |  |  |  |
| 4439 | 1537.129 | UE Conformance Test Aspects - Rel-13 LTE CA configurations | 785d? | 2015-12-15 A | 2018-12-14 A | 100% |  |  |  | finish no earlier than 2018-12-15 | R5 | 6280h | 6280h | LTE_CA_Rel13-UEConTest | 36 | Ericsson | Rel-13 | 70 |  |  |  |  |  |  |
| 4440 | 1538 | (Small) Technical Enhancements and Improvements for Rel-13 | 593d? | 2013-09-18 A | 2015-12-21 A | 100% |  |  |  | finish no earlier than 2015-12-21 | SP; CP; RP; GP | 18976h | 18976h | TEI13 | 31 |  | Rel-13 | 61 |  | PCG-31 |  |  |  |  |
| 4441 | 1539 | (Small) Test Technical Enhancements and Improvements for Rel-13 | 593d? | 2013-09-18 A | 2015-12-21 A | 100% |  |  |  | finish no earlier than 2015-12-21 | SP; CP; RP; GP | 18976h | 18976h | TEI13_Test | 31 |  | Rel-13 | 61 |  | PCG-31 |  |  |  |  |
| 4442 | 1540 | Awaiting formal work item | 593d? | 2013-09-18 A | 2015-12-21 A | 100% |  |  |  | start no earlier than 2013-09-18 | SP; CP; RP; GP | 18976h | 18976h | DUMMY | 35 |  | Rel-13 | 69 |  |  |  |  |  |  |
| 4443 | 1541 | (Small) Security Enhancements and Improvements for Rel-13 | 2372d? | 2006-12-12 A | 2015-12-21 A | 100% |  |  |  | finish no earlier than 2015-12-21 | S3 | 18976h | 18976h | SEC13 | 31 |  | Rel-13 | 61 |  | PCG-31 |  |  |  |  |
| 4444 | 1542 | Release 13 IoT related Studies | 602d? | 2013-09-12 A | 2015-12-25 A | 100% | 2014-07-31 | 2015-12-25 | 366.5d? | start no earlier than 2013-09-12 | SP; R2 | 9632h | 9632h |  |  |  | Rel-13 |  |  |  |  |  |  |  |
| 4445 | 1543 | Study on Power saving for Machine-Type Communications (MTC) devices | 266.6d? | 2014-08-12 A | 2015-08-14 A | 100% | 2014-06-18 | 2015-02-20 | 160.5d? | finish no earlier than 2015-08-14 | G2; G1 | 4000.8h | 4000.8h | FS_uPoD | 32 | China Mobile | Rel-13 | 60 | 43.869 |  | Jing Han (hanjing@chinamobile.com) | FS_uPoD |  |  |
| 4446 | 1544 | Study on Cellular system support for ultra Low Complexity and low throughput Internet of Things | 329d? | 2014-05-30 A | 2015-08-28 A | 100% | 2015-01-14 | 2015-08-28 | 163d? | finish no earlier than 2015-08-28 | G1; G2 | 5264h | 5264h | FS_IoT_LC | 33 | Vodafone | Rel-13 | 66 | 45.8xy |  | chris.pudney@vodafone.com | FS_IoT_LC | MTC, M2M |  |
| 4447 | 1545 | Study on architecture enhancements of cellular systems for ultra low complexity and low throughput Internet of Things | 196d? | 2015-03-13 A | 2015-12-11 A | 100% |  |  |  | finish no earlier than 2015-12-11 | S2 | 1568h | 1568h | FS_AE_CIoT | 34 | puneet.jain@intel.com | Rel-13 | 67 | New 23.8xx |  | puneet.jain@intel.com |  |  |  |
| 4448 | 1546 | Study on Battery Efficient Security for very low Throughput Machine Type Communication Devices | 196d? | 2015-03-13 A | 2015-12-11 A | 100% |  |  |  | finish no earlier than 2015-12-11 | S3 | 1568h | 1568h | FS_BEST_MTC_Sec | 34 | Barry, Aguibou, VODAFONE Group Plc | Rel-13 | 67 | 32.863; 33.163 |  | Barry, Aguibou, VODAFONE Group Plc |  |  |  |
| 4449 | 1547 | Study on Small data transmission enhancements for UMTS | 197d? | 2014-09-16 A | 2015-06-15 A | 100% |  |  |  | finish no earlier than 2015-06-15 | R1; R3 | 3152h | 3152h | FS_UTRA_SDATA | 33 | Ericsson | Rel-13 | 65 | 25.705 | RP-150843 | gerardo.agni.medina.acosta@ericsson.com | FS_UTRA_SDATA |  |  |
| 4450 | 1548 | Study on Application specific Congestion control for Data Communication | 531.29d? | 2012-09-17 A | 2014-09-17 A | 100% | 2012-09-13 | 2014-09-17 | 532d? | finish no earlier than 2014-09-17 | S1 | 4250.28h | 4250.28h | FS_ACDC | 29 | NTT DOCOMO | Rel-13 | 57 | 22.806 | S1-143305 | Atsushi Minokuchi (minokuchi@nttdocomo.co.jp) | FS_ACDC |  | Alain |
| 4451 | 1549 | Study on enhancements for Infrastructure based data Communication Between Devices | 266d? | 2013-09-14 A | 2014-09-17 A | 100% | 2013-09-12 | 2014-09-17 | 266d? | finish no earlier than 2014-09-17 | S1 | 2128h | 2128h | FS_eICBD | 31 | KPN | Rel-13 | 61 | 22.807 | S1-143309 | toon.norp@tno.nl | FS_eICBD | MTC, M2M | Alain |
| 4452 | 1550 | Release 13 other Studies | 602d? | 2013-09-12 A | 2015-12-25 A | 100% | 2014-07-31 | 2015-12-25 | 366.5d? | start no earlier than 2013-09-12 | SP; R2 | 9632h | 9632h |  |  |  | Rel-13 |  |  |  |  |  |  |  |
| 4453 | 1551 | Study on Isolated E-UTRAN Operation for Public Safety | 261d? | 2013-06-25 A | 2014-06-18 A | 100% | 2013-06-21 | 2014-06-18 | 262d? | finish no earlier than 2014-06-18 | S1 | 2088h | 2088h | FS_IOPS | 31 | General Dynamics | Rel-13 | 60 | 22.897 |  | paul.piggin@gd-broadband.com | FS_IOPS | Public Safety (A-A) | Alain |
| 4454 | 1552 | Study on architecture enhancements for Public Safety | 131d? | 2014-12-12 A | 2015-06-12 A | 100% |  |  |  | finish no earlier than 2015-06-12 | S2 | 1048h | 1048h | FS_IOPS_St2 | 34 |  | Rel-13 | 66 |  |  | phil.young@gd-broadband.com |  |  |  |
| 4455 | 1553 | Study on Security Aspects of Isolated E-UTRAN Operation for Public Safety | 137d? | 2015-03-12 A | 2015-09-18 A | 100% |  |  |  | finish no earlier than 2015-09-18 | S3 | 1096h | 1096h | FS_IOPS_Sec | 34 | Paul Piggin, General Dynamics UK | Rel-13 | 67 | New 33.897 |  | paul.piggin@gd-broadband.com |  |  |  |
| 4456 | 1554 | (SA66: on hold) Study on Co-ordinated packet data network gateway (P-GW) change for SIPTO | 201d? | 2013-09-13 A | 2014-06-18 A | 100% | 2013-09-12 | 2014-06-18 | 202d? | finish no earlier than 2014-06-18 | S1 | 1608h | 1608h | FS_CSIPTO | 31 | Intel | Rel-13 | 61 | 22.828 |  | Eric.siow@intel.com | FS_CSIPTO |  | Alain |
| 4457 | 1555 | Study on Flexible Mobile Service Steering | 201d? | 2013-12-13 A | 2014-09-17 A | 100% | 2013-12-11 | 2014-09-17 | 202d? | finish no earlier than 2014-09-17 | S1 | 1608h | 1608h | FS_FMSS | 32 | China Mobile | Rel-13 | 62 | 22.808 | S1-143310 | Lu Lu (lulu@chinamobile.com) | FS_FMSS |  | Alain |
| 4458 | 1556 | Study on Enhanced Calling Information Presentation | 201d? | 2013-12-13 A | 2014-09-17 A | 100% | 2013-12-11 | 2014-09-17 | 201d? | finish no earlier than 2014-09-17 | S1 | 1608h | 1608h | FS_ECIP | 32 | China Mobile | Rel-13 | 62 | 22.810 | S1-143311 | LI Xiaofan (lixiaofan@chinamobile.com | FS_ECIP |  | Alain |
| 4459 | 1557 | Study on RAN Sharing Enhancements on GERAN and UTRAN | 140d? | 2014-03-07 A | 2014-09-17 A | 100% | 2014-03-07 | 2014-09-17 | 139d? | finish no earlier than 2014-09-17 | S1 | 1120h | 1120h | FS_GUSH | 32 | Telefónica | Rel-13 | 63 | 22.852 updates |  | chris.friel@telefonica.com | FS_GUSH |  | Alain |

Notes:
- 4430: TDD case
- 4431: TDD case
- 4432: TDD case
- 4433: TDD case¦5/10/15: 36.899-13 added;
- 4434: TDD case
- 4435: TDD case
- 4436: LTE_CA_NC_B7 was completed in REL-12
- 4437: LTE_CA_NC_B7 was completed in REL-12 ¦
- 4438: LTE_CA_NC_B7 was completed in REL-12 ¦
- 4439: ¦22/3/16: Compl:0%->5%;1/7/16: Compl:5%->22%26/9/16: Compl:22%->¦2 21/3/17: Compl:39% ;; 14/1/20: 62%->100
- 4440: -
- 4441: Created upon demand of RAN5
- 4443: -
- 4444: -
- 4445: GP#65 completion 02/15=>05/15. GP#60 approved WID. Linked to Rel-12 Feature MTCe, Stage 2 BB3: UE Power Consumptions Optimizations (UEPCOP). Dec.14: 30->40%¦June2015: Compl:40%->75¦07/09/15: 75%->100
- 4446: GP#62 approved WID. Dec.14: 15->40%¦June2015: Compl:40%->75¦07/09/15: 75%->100¦14/09/15: WID:GP-140421->GP-150354
- 4447: 07/09/15: 0%->20¦07/09/15: 20%->65¦7/12/15: 65%->95¦7/3/16: 95%->100
- 4448: TR number added¦June2015: Compl:0%->10¦7/12/15: 10%->50¦11/12/15: 50%->75¦7/3/16: 75%->95¦19/9/16: 95%->100¦6/10/16: 33.163 added;
- 4449: 3/3/15: WID: RP-141861¦Stat Rep: -->RP-141859. Impacted TR number added. 1st Apr 15: Compl:30%->55% 1st Apr 15: Stat Rep: RP-141859->RP-150196 03/07/15: Compl:55%->100% 03/07/15: Stat Rep: RP-150196->RP-150843
- 4450: SP#65 completed. SP#64 TR 22.806v200 for Approval. ACDC is applicable to UTRAN and E-UTRAN. Possible overlap with RAN2 TR 36.848 Study on smart congestion mitigation in E-UTRAN (prioritising MMTEL voice over other traffic during congestion)
- 4451: SP#65 completed. TR 22.807v200 for Approval
- 4452: -
- 4453: SP#64 completed. TR 22.897v200 for Approval. Linked to Rel-12 TR 22.803 (FS_ProSe) and FeaturES in CP-150ProSe, GCSE_LTE
- 4454: June2015: Compl:0%->100
- 4455: TR added¦June2015: Compl:0%->30¦7/12/15: 30%->100
- 4456: SP#64 completed. TR 22.828v200 for Approval. Linked to FeaturES in CP-150Rel-10 LIPA_SIPTO & Rel-12 LIMONET
- 4457: SP#65 completed. TR 22.808v200 for Approval. Study supporting traffic classification and service chain selection capabilities per operators policy in order to realize efficient and flexible mobile service steering in the Gi-LAN network
- 4458: SP#65 completed. TR 22.810v200 for Approval. Linked to Multimedia Telephony Service for IMS (UID_7038), Customized Alerting Tone (CAT) UID_370028, Customized Ringing Signal (CRS) UID_380067
- 4459: SP#65 completed. Update on GERAN and UTRAN of Rel-12 TR 22.852 Study on RAN Sharing Enhancements (FS_RSE)

| ID | WBS | Task | Duration | Start | Finish | Complete | Baseline start | Baseline finish | Baseline duration | Total slack | Constraint | Resources | Work | Actual work | Acronym | PCG approved | WI rapporteur name | Release | TSG approved | MCC resp | Acronym_3GU_Export | PCG stopped | TSG stopped | Special Focus Doc | Status Report |
| --- | --- | --- | --- | --- | --- | --- | --- | --- | --- | --- | --- | --- | --- | --- | --- | --- | --- | --- | --- | --- | --- | --- | --- | --- | --- |
| 4460 | 1558 | **Study on Usage Monitoring Enhancements for Service, Application and Subscriber Group** | 934d? | 2011-06-08 A | 2014-12-12 A | 100% | 2011-06-08 | 2014-12-10 | 929d? |  |  | S2 | 13978.1h | 13978.1h | FS_UMONC_sas | 27 | China Telecom | Rel-13 | 52 | Maurice | FS_UMONC_sas |  |  |  |  |
| 4461 | 1558.1 | Deleted - SA1 part of Study on Usage Monitoring Control PCC Enhancement | 275d? | 2011-06-08 A | 2012-06-20 A | 100% | 2011-06-08 | 2012-06-20 | 275d? |  | finish no earlier than 2012-06-20 | S1 | 2200h | 2200h |  | 27 | ZTE |  | 52 | Maurice | FS_UMONC | PCG-31 | SP-58 |  |  |
| 4462 | 1558.2 | SA2 part of Study on Usage Monitoring Control PCC Enhancement | 397.26d? | 2013-06-14 A | 2014-12-12 A | 100% | 2013-06-02 | 2014-12-10 | 403d? |  | finish no earlier than 2014-12-12 | S2 | 3178.08h | 3178.08h | FS_UMONC_sas | 27 | China Telecom | Rel-13 | 52 | Maurice |  |  |  |  |  |
| 4463 | 1558.3 | Deleted - SA5 part of Study on Usage Monitoring Control enhancement | 141d? | 2012-03-02 A | 2012-09-12 A | 100% | 2012-03-02 | 2012-09-12 | 141d? |  | finish no earlier than 2012-09-12 | S5 | 1128h | 1128h |  | 27 | Huawei |  | 52 | Mirko |  | PCG-29 | SP-57 |  |  |
| 4464 | 1559 | Study on Security aspects of Integration of Single Sign-On (SSO) frameworks with 3GPP networks | 1180d? | 2010-12-28 A | 2015-06-12 A | 100% | 2010-12-16 | 2014-09-17 | 988d? |  | finish no earlier than 2015-06-12 | S3 | 9440h | 9440h | FS_SSO_Int_Sec | 26 | Ericsson | Rel-13 | 50 | Mirko | FS_SSO_Int_Sec |  |  |  |  |
| 4465 | 1560 | Study on Subscriber Privacy Impact in 3GPP | 591d? | 2013-09-17 A | 2015-12-16 A | 100% | 2013-09-12 | 2014-09-17 | 266d? |  | finish no earlier than 2015-12-16 | S3 | 4728h | 4728h | FS_SPI | 31 | China Unicom | Rel-13 | 61 | Mirko | FS_SPI |  |  |  |  |
| 4466 | 1561 | Study on Enhancements of OAM aspects of Distributed Mobility Load Balancing (MLB) SON function | 458d? | 2014-09-15 A | 2016-06-13 A | 100% | 2013-09-12 | 2014-12-10 | 326d? |  | finish no earlier than 2016-06-13 | S5 | 3664h | 3664h | FS_D_MLB_SON_OAM | 31 | Cisco | Rel-13 | 61 | Mirko | FS_D_MLB_SON_OAM |  |  | SON |  |
| 4467 | 1562 | Study on Application and Partitioning of Itf-N | 458d? | 2013-12-17 A | 2015-09-11 A | 100% | 2013-12-11 | 2014-12-10 | 261d? |  | finish no earlier than 2015-09-11 | S5 | 3664h | 3664h | FS_OAM_AP_Itf-N | 32 | China Mobile | Rel-13 | 62 | Mirko | FS_OAM_AP_Itf-N |  |  |  |  |
| 4468 | 1563 | Study on Charging aspects on Roaming End-to-end scenarios with VoLTE IMS and interconnecting networks | 393d? | 2013-12-17 A | 2015-06-12 A | 100% | 2013-12-11 | 2014-12-10 | 261d? |  | finish no earlier than 2015-06-12 | S5 | 3144h | 3144h | FS_REVOLTE_IMS_CH | 32 | Deutsche Telekom | Rel-13 | 62 | Mirko | FS_REVOLTE_IMS_CH |  |  |  |  |
| 4469 | 1564 | Study on Network Management of Virtualized Networks | 269d? | 2014-06-11 A | 2015-06-17 A | 100% | 2014-06-06 | 2015-06-17 | 269d? |  | finish no earlier than 2015-06-17 | S5 | 2152h | 2152h | FS_OAM_VIRNET | 33 | China Mobile, Huawei | Rel-13 | 64 |  | FS_OAM_VIRNET |  |  |  |  |
| 4470 | 1565 | Study on Review of dedicated 3GPP UICC features | 729d? | 2013-03-13 A | 2015-12-16 A | 100% | 2013-03-04 | 2014-09-12 | 401d? |  | finish no earlier than 2015-12-16 | C6 | 5832h | 5832h | FS_Red_UCe | 30 | BlackBerry | Rel-13 | 59 | Xavier | FS_Red_UCe |  |  |  |  |
| 4471 | 1566 | Study on Solutions for GSM/EDGE BTS Energy Saving | 458.8d? | 2011-08-30 A | 2015-11-20 A | 100% | 2009-03-10 | 2014-08-29 | 557d? |  | finish no earlier than 2015-11-20 | G1; G2 | 3670.4h | 3670.4h | FS_Energy_BTS | 25 | Nokia Networks | Rel-13 | 47 | Paolo | FS_Energy_BTS |  |  |  |  |
| 4472 | 1567 | Study on Downlink MIMO | 459d? | 2014-08-14 A | 2016-05-12 A | 100% | 2013-08-20 | 2015-02-20 | 396d? |  | finish no earlier than 2016-05-12 | G1; G2 | 4004.8h | 4004.8h | FS_DOMIMO | 30 | Nokia Networks | Rel-13 | 57 | Paolo | FS_DOMIMO |  |  |  |  |
| 4473 | 1568 | Study on MIMO OTA antenna test function for LTE | 462d? | 2013-03-18 A | 2014-12-15 A | 100% | 2013-03-15 | 2014-12-05 | 456d? |  | finish no earlier than 2014-12-15 | R4 | 3696h | 3696h | FS_LTE_MIMO_OTA_ATF | 33 | Keysight | Rel-13 | 64 |  | FS_LTE_MIMO_OTA_ATF |  |  |  | RP-142045 |
| 4474 | 1569 | Stopped at 20% - Study on UpLink MultiUser Multiple-Input Multiple-Output (UL MU-MIMO) | 481.6d? | 2014-04-17 A | 2016-02-19 A | 100% | 2014-04-17 | 2015-02-20 | 195.5d? |  | finish no earlier than 2016-02-19 | G1; G2 | 5688h | 5688h | FS_UL_MU_MIMO | 32 | Huawei | Rel-13 | 60 |  | FS_UL_MU_MIMO |  | SP#71 |  |  |
| 4475 | 1570 | Study on LTE FDD in the bands 1980-2010 MHz and 2170-2200 MHz | 854d? | 2012-09-11 A | 2015-12-15 A | 100% | 2012-09-11 | 2014-09-12 | 527d? |  | finish no earlier than 2015-12-15 | R4 | 6832h | 6832h | FS_LTE_1980_2170_Korea | 29 | KT | Rel-13 | 57 | Issam | FS_LTE_1980_2170_Korea |  |  |  | RP-151274 |
| 4476 | 1571 | Study on Positioning enhancements for E-UTRA | 524d? | 2012-05-01 A | 2014-12-15 A | 100% | 2013-04-25 | 2014-12-05 | 256d? |  | finish no earlier than 2014-12-15 | R4 | 4192h | 4192h | FS_LCSenh_LTE | 31 | Huawei | Rel-13 | 60 | Issam | FS_LCSenh_LTE |  |  |  | RP-142224 |
| 4477 | 1572 | Study on Multi-RAT joint coordination | 397d? | 2013-12-06 A | 2015-06-15 A | 100% | 2013-12-06 | 2014-12-05 | 261d? |  | finish no earlier than 2015-06-15 | R4 | 3176h | 3176h | FS_MultiRAT_JC | 32 | China Mobile | Rel-13 | 62 | Juha | FS_MultiRAT_JC |  |  | WLAN | RP-150807 |
| 4478 | 1573 | Study on Advanced Wireless Services (AWS) - Extension band for LTE | 265d? | 2013-12-16 A | 2014-12-15 A | 100% | 2013-12-09 | 2014-12-05 | 261d? |  | finish no earlier than 2014-12-15 | R4 | 2120h | 2120h | FS_LTE_AWS_EXT | 33 | Qualcomm | Rel-13 | 64 |  | FS_LTE_AWS_EXT |  |  |  | RP-141968 |
| 4479 | 1574 | Study on Indoor Positioning Enhancements for UTRA and LTE | 328d? | 2014-06-18 A | 2015-09-15 A | 100% | 2014-06-13 | 2015-09-17 | 330d? |  | finish no earlier than 2015-09-15 | R1; R4 | 5248h | 5248h | FS_UTRA_LTE_iPos_enh | 33 | NextNav | Rel-13 | 64 |  | FS_UTRA_LTE_iPos_enh |  |  |  | RP-151178 |
| 4480 | 1575 | Study on Downlink enhancements for UMTS | 199d? | 2014-09-12 A | 2015-06-15 A | 100% |  |  |  |  | finish no earlier than 2015-06-15 | R2; R1 | 3184h | 3184h | FS_UTRA_EDL | 33 | Huawei | Rel-13 | 65 |  | FS_UTRA_EDL |  |  |  | RP-150681 |
| 4481 | 1576 | Study on Elevation Beamforming/Full-Dimension (FD) MIMO for LTE | 199d? | 2014-09-12 A | 2015-06-15 A | 100% |  |  |  |  | finish no earlier than 2015-06-15 | R1 | 1592h | 1592h | FS_LTE_EBF_FDMIMO | 33 | Nokia Networks (DL), Samsung (UL) | Rel-13 | 65 |  | FS_LTE_EBF_FDMIMO |  |  |  | RP-150734 |
| 4482 | 1577 | Study on Licensed-Assisted Access using LTE | 197d? | 2014-09-16 A | 2015-06-15 A | 100% |  |  |  |  | finish no earlier than 2015-06-15 | R1; R2; R4 | 4728h | 4728h | FS_LTE_LAA | 33 | Ericsson, Huawei | Rel-13 | 65 |  | FS_LTE_LAA |  |  |  | RP-150624 |
| 4483 | 1578 | Study on EPC Signalling Improvement for Race Scenarios | 203d? | 2014-12-03 A | 2015-09-11 A | 100% |  |  |  |  | finish no earlier than 2015-09-11 | C4 | 1624h | 1624h | FS_EPC_SIG_RACE | 34 | Huawei | Rel-13 | 66 |  |  |  |  |  |  |
| 4484 | 1579 | Study on Video Enhancements in 3GPP Multimedia Services | 261d? | 2014-12-12 A | 2015-12-11 A | 100% |  |  |  |  | finish no earlier than 2015-12-11 | S4 | 2088h | 2088h | FS_VE_3MS | 34 | Ye-Kui Wang, Qualcomm Incorporated | Rel-13 | 66 |  |  |  |  |  |  |
| 4485 | 1580 | Study on possible additional configuration for LTE TDD | 197d? | 2014-12-15 A | 2015-09-15 A | 100% |  |  |  |  | finish no earlier than 2015-09-15 | R4 | 1576h | 1576h | FS_LTE_TDD_add_config | 34 | NTT DOCOMO, Hideaki Takahashi | Rel-13 | 66 |  |  |  |  |  | RP-151283 |
| 4486 | 1581 | Study on Network-Assisted Interference Cancellation and Suppression for UMTS | 197d? | 2014-12-15 A | 2015-09-15 A | 100% |  |  |  |  | finish no earlier than 2015-09-15 | R1 | 1576h | 1576h | FS_UTRA_NAICS | 34 | Huawei | Rel-13 | 66 |  |  |  |  |  | RP-151235 |
| 4487 | 1582 | Study on Enhanced Multiuser Transmissions and Network Assisted Interference Cancellation for LTE | 65d? | 2014-12-15 | 2015-03-15 |  |  |  |  | 2867d | finish no earlier than 2015-03-15 | R1 | 520h |  | FS_LTE_MUTX_NAIC | 34 | MediaTek | Rel-13 | 66 |  |  |  |  |  | RP-150213 |
| 4488 | 1583 | Study on Support of single-cell point-to-multipoint transmission in LTE | 131d? | 2014-12-15 A | 2015-06-15 A | 100% |  |  |  |  | finish no earlier than 2015-06-15 | R4 | 1048h | 1048h | FS_LTE_SC_PTM | 34 | Jeff GAO | Rel-13 | 66 |  |  |  |  |  | RP-150695 |
| 4489 | 1584 | Study on Extension of Dual Connectivity in E-UTRAN | 131d? | 2014-12-15 A | 2015-06-15 A | 100% |  |  |  |  | finish no earlier than 2015-06-15 | R3 | 1048h | 1048h | FS_LTE_dualC_ext | 34 | Samsung | Rel-13 | 66 |  |  |  |  |  | RP-150849 |
| 4490 | 1585 | Study on further enhancements of small cell higher layer aspects for LTE | 197d? | 2014-12-15 A | 2015-09-15 A | 100% |  |  |  |  | finish no earlier than 2015-09-15 | R3 | 1576h | 1576h | FS_LTE_SC_enh2_hilayer | 34 | Huawei | Rel-13 | 66 |  |  |  |  |  | RP-151243 |
| 4491 | 1586 | Study on RAN sharing enhancements for UMTS | 131d? | 2014-12-15 A | 2015-06-15 A | 100% |  |  |  |  | finish no earlier than 2015-06-15 | R3 | 1048h | 1048h | FS_RSE_UTRA_GUSH | 34 | Huawei | Rel-13 | 66 |  |  |  |  |  | RP-150684 |
| 4492 | 1587 | Study on LTE DL 4 Rx antenna ports | 65d? | 2014-12-15 A | 2015-03-13 A | 100% |  |  |  |  | finish no earlier than 2015-03-15 | R4 | 520h | 520h | FS_LTE_4Rx_AP_DL | 34 | Ericsson | Rel-13 | 66 |  |  |  |  |  | RP-150138 |
| 4493 | 1588 | Study on performance enhancements for high speed scenario in LTE | 262d? | 2014-12-15 A | 2015-12-15 A | 100% |  |  |  |  | finish no earlier than 2015-12-15 | R4 | 2096h | 2096h | FS_LTE_high_speed | 34 | NTTDoCoMo | Rel-13 | 66 |  |  |  |  |  | RP-151313 |
| 4494 | 1589 | Study on Enhanced Multiuser Transmissions and Network | 261d? | 2014-12-12 | 2015-12-11 |  |  |  |  | 2672d | finish no earlier than 2015-12-11 | R1 | 2088h |  | FS_MUIC_LTE | 34 | Pei-Kai Liao | Rel-13 | 67 |  |  |  |  |  |  |
| 4495 | 1590 | Study on regulatory aspects for flexible duplex for E-UTRAN | 133d? | 2016-06-15 A | 2016-12-15 A | 100% |  |  |  |  |  | RP | 1064h | 1064h | FS_LTE_flex_duplex_reg | 34 | LG Electronics Inc. | Rel-13 | 67 |  |  |  |  |  | RP-151307 |
| 4496 | 1591 | Study on Downlink Multiuser Superposition Transmission for LTE | 197d? | 2015-03-16 A | 2015-12-15 A | 100% |  |  |  |  | finish no earlier than 2015-12-15 | R1 | 1576h | 1576h | FS_LTE_MUST | 34 | Mediatek | Rel-13 | 67 |  |  |  |  |  | RP-151345 |
| 4497 | 1592 | Study on Measurement gap enhancement for LTE | 197d? | 2015-03-16 A | 2015-12-15 A | 100% |  |  |  |  | finish no earlier than 2015-12-15 | R4 | 1576h | 1576h | FS_LTE_meas_gap | 34 |  | Rel-13 | 67 |  |  |  |  |  | RP-151317 |
| 4498 | 1593 | Study on Phase 1 of the Support of Emergency services over WLAN | 71d? | 2015-03-12 A | 2015-06-18 A | 100% |  |  |  |  | finish no earlier than 2015-06-18 | S2 | 568h | 568h | FS_SEW | 34 | Laurent Thiebaut, Alcatel Lucent | Rel-13 | 67 |  |  |  |  |  |  |
| 4499 | 1594 | Study on EGPRS Access Security Enhancements with relation to cellular IoT | 197d? | 2015-03-12 A | 2015-12-11 A | 100% |  |  |  |  | finish no earlier than 2015-12-11 | S3 | 1576h | 1576h | FS_EASE_IoT | 34 | Vesa Torvinen, Ericsson | Rel-13 | 67 |  |  |  |  |  |  |
| 4500 | 1595 | Study on SCC AS Restoration | 1d? | 2015-06-15 A | 2015-06-15 A | 100% |  |  |  |  | start no earlier than 2015-06-15 | C4 | 8h | 8h | FS_SCCAS_RES | 35 | Hao Zhang,, China Mobile | Rel-13 | 68 |  |  |  |  |  |  |
| 4501 | 1596 | Study on S6a/S6d Shared Data Update | 130d? | 2015-06-15 A | 2015-12-11 A | 100% |  |  |  |  | finish no earlier than 2015-12-11 | C4 | 1040h | 1040h | FS_eSDU | 35 | Ulrich Wiehe, Nokia Networks | Rel-13 | 68 |  |  |  |  |  |  |
| 4502 | 1597 | Study on Network Assistance for Network Synchronization in LTE | 395d? | 2015-06-15 A | 2016-12-15 A | 100% |  |  |  |  | finish no earlier than 2016-12-15 | R3 | 3160h | 3160h | FS_LTE_NW_SYNC | 35 | Huawei | Rel-14 | 68 |  |  |  |  |  |  |
| 4503 | 1598 | Study onLTE Advanced inter-band Carrier Aggregation of Band 20 and Band 28 | 132d? | 2015-06-15 A | 2015-12-15 A | 100% |  |  |  |  | finish no earlier than 2015-12-15 | R4 | 1056h | 1056h | FS_LTE_CA_B20_B28 | 35 | TeliaSonera | Rel-13 | 68 |  |  |  |  |  | RP-151231 |
| 4504 | 1599 | Study on Impacts of the Diameter Base Protocol Specification Update | 75d? | 2015-09-07 A | 2015-12-18 A | 100% |  |  |  |  | finish no earlier than 2015-12-18 | C4 | 600h | 600h | FS_DBPU | 35 | Huawei, Peter Schmitt | Rel-13 | 69 |  |  |  |  |  |  |
| 4505 | 1600 | Study on new AWS-3/4 Band for LTE | 66d? | 2015-09-15 A | 2015-12-15 A | 100% |  |  |  |  | finish no earlier than 2015-12-15 | R4 | 528h | 528h | FS_LTE_AWS_3_4 | 35 | Dish Network | Rel-13 | 69 |  |  |  |  |  |  |
| 4506 | 1601 | Study on multi-node testing for LAA | 263d? | 2016-06-15 A | 2017-06-15 A | 100% |  |  |  |  | finish no earlier than 2017-06-15 | R4 | 2104h | 2104h | FS_LTE_LAA_multinode_test | 37 | Huawei | Rel-13 | 72 |  |  |  |  |  |  |
| 4507 | 1602 | Stopped - Study on Compliance of 3GPP SA5 specifications to the NGMN NGCOR | 1442d? | 2012-06-26 A | 2017-12-15 A | 100% | 2012-06-20 | 2015-09-16 | 854d? |  | finish no earlier than 2017-12-15 | S5 | 11536h | 11536h | FS_OAM_NGMN_NGCOR | 29 | Huawei | Rel-13 | 56 | Mirko | FS_OAM_NGMN_NGCOR |  | 80 |  |  |
| 4508 | 1603 | --- RELEASE 12 --- | 306d? | 2013-10-14 A | 2014-12-12 A | 100% | 2013-10-14 | 2014-12-10 | 304d? |  | finish no earlier than 2014-12-12 | SP; CP; RP; GP | 9792h | 9792h |  |  |  | Rel-12 |  |  |  |  |  |  |  |
| 4509 | 1604 | Stage 1 - ONLY Features | 647d? | 2011-09-27 A | 2014-03-05 A | 100% | 2011-09-27 | 2014-03-05 | 647d? |  | start no earlier than 2011-09-27 | SP; CP | 10352h | 10352h |  | 30 |  | Rel-12 | 58 |  |  |  |  |  |  |

Notes:
- 4460: SP#64 revived. Added to the Title "for Service, Application and Subscriber Group", Changed Acronym: FS_UMONC=>FS_UMONC_sas / Impacted TSs and TRs: 23.858 / WI rapporteur e-mail: Jinyan Li (lijy@ctbri.com.cn)
- 4461: SP#56 completed / Impacted TSs and TRs: 23.858 / WI rapporteur e-mail: Li.Mian@zte.com.cn
- 4462: SP#64 revived. Updated WID SP-120554=>SP-140403. Changed Justification/objectives/Rapporteut ZTE=>China Unciom. SP#58 SA2 stopped (at 70% completion). Dec.14: 80->100%. Mar 15: WID SP-140403->SP-150029 / Impacted TSs and TRs: 23.858 / WI rapporteur e-mail: Jinyan Li (lijy@ctbri.com.cn)
- 4463: SP#57 stopped / Impacted TSs and TRs: 32.858 / WI rapporteur e-mail: Hui Cai (Sarah.Cai@huawei.com)
- 4464: SP#65 moved to Rel-13. Updated WID SP-100734=>SP-140576. Completion 09/14=>06/15. Dec.14: 60->65%¦June2015: Compl:65%->100¦June2015: WID:SP-140576->SP-150368 / Impacted TSs and TRs: 33.895 / WI rapporteur e-mail: vesa.lehtovirta@ericsson.com
- 4465: SP#65 moved to Rel-13. Completion 09/14=>12/15. Related to SA1 TR 22.949 Rel-6 Study on Privacy Capability (PrivCap) UID_31030 studied generalized privacy capability (protection of personal data and non-disclosure of identity). Dec.14: 80->85¦June2015 / Impacted TSs and TRs: 33.849 / WI rapporteur e-mail: Feng Gao (gaofeng149@chinaunicom.cn)
- 4466: SP#64 completion 06/14=>12/14. Dec.14: 20->25%, CD: 12/14->06/15¦June2015: Compl:25%->30¦7/12/15: 30%->45¦7/3/16: 45%->50¦13/6/16: 50%->100 / Impacted TSs and TRs: 32.860 / WI rapporteur e-mail: Vladimir Yanover (vyanover@cisco.com)
- 4467: -Dec.14: 15->30%, CD: 12/14->09/15¦June2015: Compl:30%->60¦07/09/15: 60%->100 / Impacted TSs and TRs: 32.861 / WI rapporteur e-mail: Li Jian (lijian@chinamobile.com), Hu Yaxi (huyaxi@cmdi.chinamobile.com)
- 4468: SP#64 moved to Rel-13. Completion 06/14=>12/14. Dec.14: 35->55, CD: 12/14->06/15. Mar 15: 55->75%¦June2015: Compl:75%->100 / Impacted TSs and TRs: 32.849 / WI rapporteur e-mail: Roland Jesske (r.jesske@telekom.de)
- 4469: Dec.14: 10->25%. Mar 15: 25->60%¦June2015: Compl:60%->85¦07/09/15: 85%->100 / Impacted TSs and TRs: 32.842 / WI rapporteur e-mail: Liu Jinglei (liujinglei@chinamobile.com), zoulan@huawei.com
- 4470: CP#65 TR 31.901v100 for Information. Moved to Rel-13. Completion 09/14=>12/15. Waiting for feedback from external organizations (PTCRB/PVG). Dec.14: 65->100% / Impacted TSs and TRs: 31.901 / WI rapporteur e-mail: Adrian Buckley (abuckley@blackberry.com)
- 4471: GP#63 moved to Rel-13. Completion 08/14=>11/14. GP#55 TR 45.926v100 for Information. GP#47 approved WID. Dec.14: 90->95%. 3/3/15: start date corrected (was 03/09). 7/9/15: FCD: 8/15->11/15¦7/12/15: 95%->100 / Impacted TSs and TRs: 45.926 / WI rapporteur e-mail: juergen.hofmann@nokia.com
- 4472: GP#62 completion 08/14=>02/15. Moved to Rel-13. GP#57 approved WID. Dec.14: 50->65%, CD: 02/15->05/15. 7/9/15: FCD: 11/15->02/16¦2/3/16: 65%->75, FCD: 02/16->05/16¦11/9/17: 75%->100 / Impacted TSs and TRs: 45.8xy / WI rapporteur e-mail: juergen.hofmann@nokia.com
- 4473: CD:Thu 11/12/14->Mon 15/12/14¦Compl:60%->100%¦Stat Rep: RP-141124->RP-142045 / Impacted TSs and TRs: 36.509; new 37.978 / WI rapporteur e-mail: Moray_Rumney@keysight.com
- 4474: GP#62 completion 11/14=>02/15. GP#60 approved WID. Dec.14: 02/15->05/15. 02/03/16: stopped at 20% / Impacted TSs and TRs: 45.876 / WI rapporteur e-mail: Chao Luo (chluo@huawei.com)
- 4475: CD:Thu 11/12/14->Sun 15/03/15¦Compl:85%->90%¦Stat Rep: RP-141153->RP-141851 1st Apr 15: CD:Sun 15/03/15->Mon 15/06/15 1st Apr 15: WID: RP-141154->RP-150119 1st Apr 15: Stat Rep: RP-141851->RP-150120 03/07/15: CD:Mon 15/06/15->Tue 15/09/15 03/07/15: S / Impacted TSs and TRs: LTE 36.861 / WI rapporteur e-mail: Chungwoo HWANG (cwhwang@kt.com)
- 4476: WID: RP-140667->RP-130680¦Stat Rep: RP-140639->RP-142224. 3/3/15: R1 removed as 2nd responsible WG / Impacted TSs and TRs: LTE 36.855 / WI rapporteur e-mail: Jie Cui (cuijie@huawei.com)
- 4477: ¦WID: RP-142043->RP-132086¦Stat Rep: RP-141301->RP-141838 1st Apr 15: Compl:55%->85% 1st Apr 15: WID: RP-132086->RP-150417 1st Apr 15: Stat Rep: RP-141838->RP-150187 03/07/15: Compl:85%->100% 03/07/15: Stat Rep: RP-150187->RP-150807 / Impacted TSs and TRs: UTRA; LTE 37.870 / WI rapporteur e-mail: Kimba Dit Adamou, Boubacar (jinba@chinamobile.com)
- 4478: CD:Thu 11/12/14->Mon 15/12/14¦Compl:10%->100%¦Stat Rep: RP-141429->RP-141968. 5/5/15: 2nd TR number added (to be clarified why two TR for a same topic) / Impacted TSs and TRs: 36.849; 36.869 / WI rapporteur e-mail: Gene Fong (gfong@qti.qualcomm.com)
- 4479: CD:Thu 17/09/15->Tue 15/09/15¦Compl:0%->8%¦Stat Rep: RP-141101->RP-141818 1st Apr 15: Compl:8%->30% 1st Apr 15: Stat Rep: RP-141818->RP-150080 03/07/15: Compl:30%->75% 03/07/15: Stat Rep: RP-150080->RP-150595 29/09/15: Compl:75%->100% 29/09/15: Stat / Impacted TSs and TRs: UTRA; LTE 37.857 / WI rapporteur e-mail: Vogedes Jerome (jvogedes@NextNav.com)
- 4480: WID: RP-141901¦Stat Rep: -->RP-142233 1st Apr 15: Compl:40%->80% 1st Apr 15: WID: RP-141901->RP-150224 1st Apr 15: Stat Rep: RP-142233->RP-150223. 5/5/15: R4 replaced by R1 (correction mistake) 03/07/15: Compl:80%->100% 03/07/15: Stat Rep: RP-150223-> / Impacted TSs and TRs: UTRA 25.706 / WI rapporteur e-mail: jun.chen@huawei.com
- 4481: 3/3/15: WID: RP-141831¦Stat Rep: -->RP-141822, impacted TR number added. 1st Apr 15: Compl:30%->45% 1st Apr 15: Stat Rep: RP-141822->RP-150346. 5/5/15: "R4" replaced by "R1" (correction mistake) 03/07/15: Compl:45%->100% 03/07/15: WID: RP-141831->RP-1 / Impacted TSs and TRs: 36.897 / WI rapporteur e-mail: bishwarup.mondal@nsn.com, hyoungju.ji@samsung.com
- 4482: 3/3/15: WID: RP-141817¦Stat Rep: -->RP-141816. Impacted TR number added. 1st Apr 15: Compl:30%->40% 1st Apr 15: Stat Rep: RP-141816->RP-150414 03/07/15: Compl:40%->100% 03/07/15: Stat Rep: RP-150414->RP-150624 / Impacted TSs and TRs: 36.889 / WI rapporteur e-mail: havish.koorapaty@ericsson.com, david.mazzarese@huawei.com
- 4483: Mar15: 0->20%¦June2015: Compl:20%->80¦07/09/15: 80%->95¦7/12/15: 95%->100 / Impacted TSs and TRs: New 29.811
- 4484: Mar. 15: 0->20%¦June2015: Compl:20%->40¦07/09/15: 40%->80¦7/12/15: 80%->100 / WI rapporteur e-mail: yekuiw@qti.qualcomm.com
- 4485: TR 36.825 rapporteur: CATT. TR number added. 1st Apr 15: Compl:0%->5% 1st Apr 15: Stat Rep: ->RP-150151 03/07/15: Compl:5%->35% 03/07/15: WID: RP-142248->RP-150652 03/07/15: Stat Rep: RP-150151->RP-150805 29/09/15: Compl:35%->100% 29/09/15: Stat Rep: R / Impacted TSs and TRs: 36.825 / WI rapporteur e-mail: NTT DOCOMO
- 4486: TS number added 1st Apr 15: Compl:0%->20% 1st Apr 15: WID: RP-142250->RP-150174 1st Apr 15: Stat Rep: ->RP-150175. 5/5/15: "R4" replaced by "R1" (correction mistake) 03/07/15: Compl:20%->65% 03/07/15: Stat Rep: RP-150175->RP-150679 29/09/15: Compl:65%- / Impacted TSs and TRs: 25.766 / WI rapporteur e-mail: Huawei
- 4487: 1st Apr 15: CD:Tue 15/12/15->Sun 15/03/15 1st Apr 15: Stat Rep: ->RP-150213. 5/5/15: "R4" replaced by "R1" (correction mistake) / WI rapporteur e-mail: MediaTek
- 4488: deleted 660062 (duplicated). 29/1: TR number added 1st Apr 15: Compl:0%->25% 1st Apr 15: WID: RP-142205->RP-150177 1st Apr 15: Stat Rep: ->RP-150176 03/07/15: Compl:25%->100% 03/07/15: Stat Rep: RP-150176->RP-150695 / Impacted TSs and TRs: 36.890 / WI rapporteur e-mail: gaoyongqiang@huawei.com
- 4489: 1st Apr 15: WID: RP-142257->RP-150170 1st Apr 15: Stat Rep: ->RP-150163 03/07/15: Compl:85%->100% 03/07/15: Stat Rep: RP-150163->RP-150849. 7/10/15: responsible group corrected (R4->R3) / Impacted TSs and TRs: 36.875 / WI rapporteur e-mail: Samsung
- 4490: 03/07/15: Compl:10%->30% 03/07/15: Stat Rep: RP-150226->RP-150683 29/09/15: Compl:30%->100% 29/09/15: Stat Rep: RP-150683->RP-151243. 7/10/15: responsible group corrected (R4->R3) and TS (37.876->36.876) / Impacted TSs and TRs: 36.876 / WI rapporteur e-mail: Huawei
- 4491: 03/07/15: Compl:10%->100% 03/07/15: WID: RP-142284->RP-150686 03/07/15: Stat Rep: RP-150227->RP-150684. 7/10/15: responsible group corrected (R4->R3) / Impacted TSs and TRs: 25.756 / WI rapporteur e-mail: Huawei
- 4492: 1st Apr 15: Compl:0%->100% 1st Apr 15: WID: RP-142299->RP-150457 1st Apr 15: Stat Rep: ->RP-150138 / WI rapporteur e-mail: Ericsson
- 4493: TR Rapporteur is Huawei 1st Apr 15: Compl:0%->5% 1st Apr 15: WID: RP-142307->RP-150159 1st Apr 15: Stat Rep: ->RP-150517 03/07/15: Compl:5%->40% 03/07/15: Stat Rep: RP-150517->RP-150793 29/09/15: Compl:40%->80% 29/09/15: CD:Tue 15/09/15->Tue 15/12/15 2 / WI rapporteur e-mail: NTTDoCoMo
- 4494: TR added / Impacted TSs and TRs: 36.891 / WI rapporteur e-mail: pk.liao@mediatek.com
- 4495: TR added 03/07/15: Compl:0%->5% 03/07/15: Stat Rep: -->RP-150770 29/09/15: Compl:5%->100% 29/09/15: Stat Rep: RP-150770->RP-151307 / Impacted TSs and TRs: 36.882
- 4496: TR added 03/07/15: Compl:0%->30% 03/07/15: WID: RP-150496->RP-151100 03/07/15: Stat Rep: -->RP-150857 29/09/15: Compl:30%->50% 29/09/15: Stat Rep: RP-150857->RP-151345 / Impacted TSs and TRs: 36.859
- 4497: 03/07/15: Compl:0%->15% 03/07/15: CD:Thu 10/12/15->Tue 15/12/15 03/07/15: Stat Rep: ->RP-150754 03/07/15: Release: REL-13->Rel-13. Aug 15: TR numb added 29/09/15: Compl:15%->65% 29/09/15: Stat Rep: RP-150754->RP-151317 / Impacted TSs and TRs: 36.894
- 4498: June2015: Compl:0%->100, SP-150151->SP-150251 / Impacted TSs and TRs: new 23.771 / WI rapporteur e-mail: Laurent.thiebaut@alcatel-lucent.com
- 4499: TR added¦June2015: Compl:0%->25¦7/12/15: 25%->70¦28/1/16: 33.420 added¦7/3/16: 70%->100 / Impacted TSs and TRs: New 33.860; 33.420
- 4500: 07/09/15: 5%->20¦7/12/15: 20%->100 / Impacted TSs and TRs: New 29.812 / WI rapporteur e-mail: zhanghao@chinamobile.com
- 4501: 07/09/15: 0%->20¦7/12/15: 20%->100 / Impacted TSs and TRs: New 29.813 / WI rapporteur e-mail: ulrich.wiehe@nokia.com
- 4502: Aug 15: TR numb added 29/09/15: Compl:0%->15% 29/09/15: WID: RP-151084->RP-151252 29/09/15: Stat Rep: -->RP-151240 22/3/16: Compl:60%->80%¦22/3/16: CD:Tue 15/03/16->Wed 15/06/16¦ ¦ / Impacted TSs and TRs: New 36.898
- 4503: 29/09/15: Compl:0%->20% 29/09/15: WID: RP-151101->RP-151515 29/09/15: Stat Rep: -->RP-151231
- 4504: 7/3/16: 0%->79¦13/6/16: 79%->99¦2/12/16: 99%->100 / Impacted TSs and TRs: 29.274; 29.060; 23.003; 29.272; 29.002; 29.305; 23.008; 29.230; 29.303; 23.007; 24.301; 24.008
- 4505: Impacted TSs and TRs: 36.870
- 4506: coexistence testing for REL-13 WI LTE_LAA26/9/16: Compl:0%->10%26/9/16: WID: RP-161197->RP-161672¦20/12/16: Compl:10%->30%¦20/12/16: CD:Thu 15/12/16->Wed 15/03/17¦20/12/16: WID: RP-161672->RP-162144¦21/3/17: CD:Wed 15/03/17->Thu 15/06/17;
- 4507: SP#65 updated WID SP-140349=>SP-140539. Dec.14: 35->45, 12/14: 28.821 added. Mar 15: 45->50%¦June2015: Compl:50%->60. 07/09/15: FCD: 09/15->12/15¦7/12/15: FCD:12/15->03/16¦21/3/17:marked as stopped, was 60% / Impacted TSs and TRs: 32.837; 28.821 / WI rapporteur e-mail: zoulan@huawei.com
- 4508: -
- 4509: -

| ID | WBS | Task | Duration | Start | Finish | Complete | Baseline start | Baseline finish | Baseline duration | Constraint | Resources | Work | Actual work | Acronym | PCG approved | Impacted TSs and TRs | WI rapporteur name | WI rapporteur e-mail | Release | TSG approved | MCC resp | Special Focus Doc | Acronym_3GU_Export | PCG stopped | TSG stopped |
| --- | --- | --- | --- | --- | --- | --- | --- | --- | --- | --- | --- | --- | --- | --- | --- | --- | --- | --- | --- | --- | --- | --- | --- | --- | --- |
| 4510 | 1605 | **SIPTO Service Continuity of IP Data Session** | 262d? | 2010-09-23 A | 2011-09-21 A | 100% | 2010-09-23 | 2011-09-21 | 262d? |  | S1 | 4176h | 4176h | SIPTO_SC | 25 | Stage 1 | Vodafone | mona.mustapha@vodafone.com | Rel-12 | 49 | Alain | HNB | SIPTO_SC |  |  |
| 4511 | 1605.1 | Stage 1 for SIPTO Service Continuity of IP Data Session | 262d? | 2010-09-23 A | 2011-09-21 A | 100% | 2010-09-23 | 2011-09-21 | 262d? | finish no earlier than 2011-09-21 | S1 | 2080h | 2080h | SIPTO_SC-SA1 | 25 | 22.101; 22.220 | Vodafone | mona.mustapha@vodafone.com | Rel-12 | 49 | Alain | HNB |  |  |  |
| 4512 | 1606 | **Interworking between Mobile Operators using the Evolved Packet System and Data Application Providers** | 792d? | 2010-12-16 A | 2013-12-11 A | 100% | 2010-12-16 | 2013-12-11 | 792d? |  | S1; S2 | 22794.7h | 22794.7h | MOSAP | 26 | Stage 1 | Cisco | Vojislav Vucetic (vvucetic@cisco.com) | Rel-12 | 50 | Alain |  | MOSAP |  |  |
| 4513 | 1606.1 | Stage 1 for MOSAP | 202d? | 2010-12-16 A | 2011-09-21 A | 100% | 2010-12-16 | 2011-09-21 | 202d? | finish no earlier than 2011-09-21 | S1 | 1600h | 1600h | MOSAP-SA1 | 26 | 22.278 | Cisco | Vojislav Vucetic (vvucetic@cisco.com) | Rel-12 | 50 | Alain |  |  |  |  |
| 4514 | 1606.2 | TR on Stage 2 for MOSAP | 669d? | 2011-06-06 A | 2013-12-11 A | 100% | 2011-06-06 | 2013-12-11 | 669d? | finish no earlier than 2012-12-12 | S2 | 5338.74h | 5338.74h | MOSAP-SA2TR | 27 | new 23.862 | Intel | chang.hong.shan@intel.com | Rel-12 | 52 | Maurice |  |  |  |  |
| 4515 | 1606.3 | Deleted - Stage 2 for MOSAP | 399d? | 2011-06-14 A | 2012-12-12 A | 100% | 2011-06-14 | 2012-12-12 | 399d? | finish no earlier than 2012-12-12 | S2 | 3184h | 3184h | MOSAP-SA2Del | 27 | TBD | Intel | chang.hong.shan@intel.com | Rel-12 | 52 | Maurice |  |  | PCG-30 | SP-58 |
| 4516 | 1607 | **IMS Network-Independent Public User Identities** | 275d? | 2011-06-08 A | 2012-06-20 A | 100% | 2011-06-08 | 2012-06-20 | 275d? |  | S1 | 4390.4h | 4390.4h | INIPUI | 27 | Stage 1 | Vodafone | mona.mustapha@vodafone.com | Rel-12 | 52 | Alain |  | INIPUI |  |  |
| 4517 | 1607.1 | Stage 1 for IMS Network-Independent Public User Identities | 275d? | 2011-06-08 A | 2012-06-20 A | 100% | 2011-06-08 | 2012-06-20 | 275d? | finish no earlier than 2012-06-20 | S1 | 2190.4h | 2190.4h | INIPUI-SA1 | 27 | 22.115; 22.228 | Vodafone | mona.mustapha@vodafone.com | Rel-12 | 52 | Alain |  |  |  |  |
| 4518 | 1608 | **Service and Media Reachability for Users over Restrictive Firewalls** | 198d? | 2011-09-21 A | 2012-06-20 A | 100% | 2011-09-21 | 2012-06-20 | 198d? |  | S1 | 3161.66h | 3161.66h | SMURFs | 27 | Stage 1 | Vodafone | mona.mustapha@vodafone.com | Rel-12 | 53 | Alain |  | SMURFs |  |  |
| 4519 | 1608.1 | Stage 1 for Service and Media Reachability for Users over Restrictive Firewalls | 198d? | 2011-09-21 A | 2012-06-20 A | 100% | 2011-09-21 | 2012-06-20 | 198d? | finish no earlier than 2012-06-08 | S1 | 1577.66h | 1577.66h | SMURFs-SA1 | 27 | 22.278 | Vodafone | mona.mustapha@vodafone.com | Rel-12 | 53 | Alain |  |  |  |  |
| 4520 | 1609 | **Advanced IP Interconnection of Services (IPXS) for national interconnect** | 139d? | 2012-03-06 A | 2012-09-12 A | 100% | 2012-03-06 | 2012-09-12 | 139d? |  | S1 | 2208h | 2208h | IPXSNAT | 28 | Stage 1 | KPN | toon.norp@tno.nl | Rel-12 | 55 | Alain |  | IPXSNAT |  |  |
| 4521 | 1609.1 | Stage 1 for Advanced IP Interconnection of Services (IPXS) for national interconnect | 139d? | 2012-03-06 A | 2012-09-12 A | 100% | 2012-03-06 | 2012-09-12 | 139d? | finish no earlier than 2012-09-12 | S1 | 1096h | 1096h | IPXSNAT-SA1 | 28 | 22.228 CR#0161 | KPN | toon.norp@tno.nl | Rel-12 | 55 | Alain |  |  |  |  |
| 4522 | 1610 | **Integration of Single Sign-On (SSO) frameworks with 3GPP networks** | 137d? | 2012-03-08 A | 2012-09-12 A | 100% | 2012-03-08 | 2012-09-12 | 137d? |  | S1 | 2184h | 2184h | SSO_Int | 28 | Stage 1 | InterDigital | christopher.wallace@interdigital.com | Rel-12 | 55 | Alain |  | SSO_Int |  |  |
| 4523 | 1610.1 | Stage 1 for Integration of Single Sign-On (SSO) frameworks with 3GPP networks | 137d? | 2012-03-08 A | 2012-09-12 A | 100% | 2012-03-08 | 2012-09-12 | 137d? | finish no earlier than 2012-09-12 | S1 | 1088h | 1088h | SSO_Int-SA1 | 28 | 22.101 | InterDigital | christopher.wallace@interdigital.com | Rel-12 | 55 | Alain |  |  |  |  |
| 4524 | 1611 | **Explicit Communication Transfer Blind (ECT Blind) service interactions** | 3d? | 2012-06-18 A | 2012-06-20 A | 100% | 2012-06-18 | 2012-06-20 | 3d? |  | S1 | 48h | 48h | ECTB | 29 | Stage 1 | Orange | philippe.lottin@orange.com | Rel-12 | 56 | Alain |  | ECTB |  |  |
| 4525 | 1611.1 | Stage 1 for Explicit Communication Transfer Blind (ECT Blind) service interactions | 3d? | 2012-06-18 A | 2012-06-20 A | 100% | 2012-06-18 | 2012-06-20 | 3d? | finish no earlier than 2012-06-20 | S1 | 24h | 24h | ECTB-SA1 | 29 | 22.173 | Orange | philippe.lottin@orange.com | Rel-12 | 56 | Alain |  |  |  |  |
| 4526 | 1612 | **IMS access via Digital Video Broadcast - Return Channel via Satellite (DVB-RCS2)** | 162d? | 2012-02-02 A | 2012-09-12 A | 100% | 2012-02-02 | 2012-09-12 | 162d? |  | S1 | 2584h | 2584h | IMSSat | 29 | Stage 1 | KPN | toon.norp@tno.nl | Rel-12 | 57 | Alain |  | IMSSat |  |  |
| 4527 | 1612.1 | Stage 1 for IMS access via DVB-RCS2 | 162d? | 2012-02-02 A | 2012-09-12 A | 100% | 2012-02-02 | 2012-09-12 | 162d? | finish no earlier than 2012-09-12 | S1 | 1288h | 1288h | IMSSat-SA1 | 29 | 22.228 | KPN | toon.norp@tno.nl | Rel-12 | 57 | Alain |  |  |  |  |
| 4528 | 1613 | **Sequential Flexible Alerting** | 3d? | 2012-12-10 A | 2012-12-12 A | 100% | 2012-12-10 | 2012-12-12 | 3d? |  | S1 | 48h | 48h | SEQ_FA | 30 | Stage 1 | Orange | bruno.tossou@orange-ftgroup.com | Rel-12 | 58 | Alain |  | IMSSat |  |  |
| 4529 | 1613.1 | Stage 1 for Sequential Flexible Alerting | 3d? | 2012-12-10 A | 2012-12-12 A | 100% | 2012-12-10 | 2012-12-12 | 3d? | finish no earlier than 2012-12-12 | S1 | 24h | 24h | SEQ_FA | 30 | 22.173 | Orange | bruno.tossou@orange-ftgroup.com | Rel-12 | 58 | Alain |  |  |  |  |
| 4530 | 1614 | **Language and Modality Information for communications** | 63d? | 2012-12-11 A | 2013-03-06 A | 100% | 2012-12-11 | 2013-03-06 | 63d? |  | S1 | 1008h | 1008h | LangInfo | 30 | Stage 1 | Orange | philippe.lottin@orange.com | Rel-12 | 58 | Alain |  | LangInfo |  |  |
| 4531 | 1614.1 | Stage 1 for Language and Modality Information for communications | 63d? | 2012-12-11 A | 2013-03-06 A | 100% | 2012-12-11 | 2013-03-06 | 63d? | finish no earlier than 2013-03-06 | S1 | 504h | 504h | LangInfo-SA1 | 30 | 22.228 | Orange | philippe.lottin@orange.com | Rel-12 | 58 | Alain |  |  |  |  |
| 4532 | 1615 | **Emergency Session Identification** | 3d? | 2013-03-04 A | 2013-03-06 A | 100% | 2013-03-04 | 2013-03-06 | 3d? |  | S1 | 48h | 48h | ESID | 30 | Stage 1 | Telecom Italia | carmen.catalano@telecomitalia.it | Rel-12 | 59 | Alain |  | ESID |  |  |
| 4533 | 1615.1 | Stage 1 for Emergency Session Identification | 3d? | 2013-03-04 A | 2013-03-06 A | 100% | 2013-03-04 | 2013-03-06 | 3d? | finish no earlier than 2013-03-06 | S1 | 24h | 24h | ESID-SA1 | 30 | 22.101 | Telecom Italia | carmen.catalano@telecomitalia.it | Rel-12 | 59 | Alain |  |  |  |  |

Notes:
- 4510: SP#57 moved to Rel-12 (Reason: Stage 2 for requirements in TS 22.101 clause 4.3.5 have not been implemented in Rel-11). Linked to Rel-10 Local IP Access and Selected Internet IP Traffic Offload (LIPA_SIPTO)
- 4511: SP#57 moved to Rel-12. SP#53 completed
- 4512: SP#58 Stage 2 stopped (TR only, no normative work done)
- 4513: SP#53 completed
- 4514: SP#62 completed. TR 23.862v200 for Approval. SP#58 frozen as v100.
- 4515: SP#58 stopped (no normative work done)
- 4516: Triggered by Rel-11 TR 22.894 (FS_INIPUI)
- 4517: SP#56 re-completed. Updated WID SP-110381=>SP-120425 (Re-opened & moved to Rel-12 by adding new reqs & removing reqs from Rel-11). SP#53 Rel-11 Stage 1 completed
- 4518: SP#56 Stage 1 completed
- 4519: SP#56 completed
- 4520: SP#57 Stage 1 completed. Linked to Rel-11 Feature Advanced IP Interconnection of Services (IPXS) UID_470051.
- 4521: SP#57 completed
- 4522: SP#57 Stage 1 completed. Triggered by Rel-12 TR 22.895. Linked to SA3 33.8xy (Study on Security aspects of SSO_Int), 33.914 (SSO application security for common IMS based on SIP Digest), 33.924 (i/w GBA and OpenID), 33.980 (i/w GBA and Liberty Alliance)
- 4523: SP#57 completed
- 4524: SP#56 WID approved & Stage 1 completed
- 4525: SP#56 new WID approved & work completed. Clarify the service interactions between ECT Blind and other MMTEL Supplementary Services
- 4526: SP#57 Stage 1 completed. Integrate Satcom access with IMS. Specify DVB-RCS2 as an IP Connectivity Access Network for IMS
- 4527: SP#57 completed. Definition of DVB-RCS2 as a non-3GPP IP Connectivity Access Network for IMS
- 4528: SP#58 approved WID & Stage 1 completed. Currently Flexible Alerting (FA) group members are simultaneously alerted by the incoming call. Add the possibility to alert FA group members sequentially. 22/01: acronym modified
- 4529: SP#58 approved WID & Stage 1 completed
- 4530: SP#59 Stage 1 completed. Triggered by Rel-11 Study on Non Voice Emergency Services (FS_NOVES) TR 22.871 use case 10
- 4531: SP#59 completed. Updated WID SP-120937=>SP-130108
- 4532: SP#59 Stage 1 completed.
- 4533: SP#59 completed (22.101 CR#0445)

| ID | WBS | Task | Duration | Start | Finish | Complete | Baseline start | Baseline finish | Baseline duration | Constraint | Resources | Work | Actual work | Acronym | PCG approved | WI rapporteur name | WI rapporteur e-mail | Release | TSG approved | MCC resp | PCG stopped | TSG stopped | Acronym_3GU_Export | Special Focus Doc | Status Report |
| --- | --- | --- | --- | --- | --- | --- | --- | --- | --- | --- | --- | --- | --- | --- | --- | --- | --- | --- | --- | --- | --- | --- | --- | --- | --- |
| 4534 | 1616 | **Deleted - Application and Service Access Control** | 77d? | 2013-03-06 A | 2013-06-19 A | 100% | 2013-03-06 | 2013-06-19 | 77d? |  | S1 | 1224h | 1224h | ASAC | 30 | NTT DOCOMO | Atsushi Minokuchi (minokuchi@nttdocomo.co.jp) | Rel-12 | 59 | Alain | PCG-31 | SP-60 | ASAC |  |  |
| 4535 | 1616.1 | Deleted - Stage 1 for Application and Service Access Control | 77d? | 2013-03-06 A | 2013-06-19 A | 100% | 2013-03-06 | 2013-06-19 | 77d? | finish no earlier than 2013-06-19 | S1 | 608h | 608h | ASAC-SA1del | 30 | NTT DOCOMO | Atsushi Minokuchi (minokuchi@nttdocomo.co.jp) | Rel-12 | 59 | Alain | PCG-31 | SP-60 |  |  |  |
| 4536 | 1617 | **Prevention of Mobile-Originating signalling and/or data traffic of UE in Connected mode** | 3d? | 2013-03-04 A | 2013-03-06 A | 100% | 2013-03-04 | 2013-03-06 | 3d? |  | S1 | 48h | 48h | PMOC | 30 | NTT DOCOMO | Atsushi Minokuchi (minokuchi@nttdocomo.co.jp) | Rel-12 | 59 | Alain |  |  | PMOC |  |  |
| 4537 | 1617.1 | Stage 1 for Prevention of Mobile-Originating signalling and/or data traffic of UE in Connected mode | 3d? | 2013-03-04 A | 2013-03-06 A | 100% | 2013-03-04 | 2013-03-06 | 3d? | finish no earlier than 2013-03-06 | S1 | 24h | 24h | PMOC-SA1 | 30 | NTT DOCOMO | Atsushi Minokuchi (minokuchi@nttdocomo.co.jp) | Rel-12 | 59 | Alain |  |  |  |  |  |
| 4538 | 1618 | SA1/SA2 Features | 216d? | 2013-05-17 A | 2014-03-07 A | 100% | 2013-05-17 | 2014-03-07 | 216d? | finish no earlier than 2014-03-07 | SP; CP; RP | 5184h | 5184h |  | 30 |  |  | Rel-12 | 58 |  |  |  |  |  |  |
| 4539 | 1619 | **LIPA Mobility and SIPTO at the Local Network** | 898d? | 2010-10-15 A | 2014-03-06 A | 100% | 2010-10-15 | 2014-03-06 | 898d? |  | S2; C4; C1; R3 | 87994h | 87994h | LIMONET | 26 | Huawei | zhufenqin@huawei.com | Rel-12 | 50 | Maurice |  |  | LIMONET | HNB |  |
| 4540 | 1619.1 | TR on Stage 2 for LIPA Mobility and SIPTO at the Local Network | 580.85d? | 2010-10-15 A | 2013-03-06 A | 100% | 2010-10-15 | 2013-03-06 | 580.85d? | finish no earlier than 2013-03-06 | S2 | 4646.8h | 4646.8h | LIMONET-SA3 | 26 | Huawei | zhufenqin@huawei.com | Rel-12 | 50 | Maurice |  |  |  | HNB |  |
| 4541 | 1619.2 | **BB1: SIPTO at the Local Network** | 892d? | 2010-10-22 A | 2014-03-05 A | 100% | 2010-10-22 | 2014-03-05 | 892d? |  | S2 | 31685.6h | 31685.6h | LIMONET-SIPTO | 26 | Huawei | zhufenqin@huawei.com | Rel-12 | 50 | Maurice |  |  | LIMONET-SIPTO | HNB |  |
| 4542 | 1619.2.1 | Stage 2 for SIPTO at the Local Network | 655.85d? | 2010-10-22 A | 2013-06-19 A | 100% | 2010-10-22 | 2013-06-19 | 655.85d? | finish no earlier than 2013-06-19 | S2 | 5246.8h | 5246.8h | LIMONET-SIPTO-SA2 | 26 | Huawei | zhufenqin@huawei.com | Rel-12 | 50 | Maurice |  |  |  | HNB |  |
| 4543 | 1619.2.2 | **Stage 3 CN aspects of SIPTO at the Local Network** | 649d? | 2011-09-24 A | 2014-03-05 A | 100% | 2011-09-24 | 2014-03-05 | 649d? |  | C4; C1 | 19680h | 19680h | LIMONET-SIPTO | 27 | Huawei | peter.schmitt@huawei.com | Rel-12 | 53 | Kimmo |  |  |  | HNB |  |
| 4544 | 1619.2.2.1 | CT4 part of Stage 3 CN aspects of SIPTO at the Local Network | 518d? | 2011-09-24 A | 2013-09-06 A | 100% | 2011-09-24 | 2013-09-06 | 518d? | finish no earlier than 2013-09-06 | C4 | 4136h | 4136h | LIMONET-SIPTO-CT4 | 27 | Huawei | peter.schmitt@huawei.com | Rel-12 | 53 | Kimmo |  |  |  | HNB |  |
| 4545 | 1619.2.2.2 | CT1 part of Stage 3 CN aspects of SIPTO at the Local Network | 646d? | 2011-09-24 A | 2014-03-05 A | 100% | 2011-09-24 | 2014-03-05 | 646d? | finish no earlier than 2014-01-29 | C1 | 5160h | 5160h | LIMONET-SIPTO-CT1 | 27 | Huawei | peter.schmitt@huawei.com | Rel-12 | 53 | Frederic |  |  |  | HNB |  |
| 4546 | 1619.3 | **RAN aspects for SIPTO at the Local Network** | 269d? | 2013-03-04 A | 2014-03-06 A | 100% | 2013-03-04 | 2014-03-06 | 269d? |  | R3 | 4272h | 4272h | LIMONET-RAN | 30 | Huawei | zheng.zhou@huawei.com | Rel-12 | 59 | Juha |  |  | LIMONET-RAN | HNB |  |
| 4547 | 1619.3.1 | Core part: RAN aspects for SIPTO at the Local Network | 266d? | 2013-03-04 A | 2014-03-06 A | 100% | 2013-03-04 | 2014-03-06 | 266d? | finish no earlier than 2014-03-06 | R3 | 2120h | 2120h | LIMONET-RAN-Core | 30 | Huawei | zheng.zhou@huawei.com | Rel-12 | 59 | Juha |  |  | LIMONET-RAN-Core | HNB | RP-131512 |
| 4548 | 1619.4 | **Deleted - BB2: Stand-alone L-GW and associated Mobility for LIPA and SIPTO at the Local Network** | 566d? | 2010-10-22 A | 2012-12-12 A | 100% | 2010-10-22 | 2012-12-12 | 566d? |  | S2 | 18653.6h | 18653.6h | LIMONET-LIPA | 26 | Huawei | zhufenqin@huawei.com | Rel-12 | 50 | Maurice | PCG-30 | SP-58 | LIMONET-LIPA | HNB |  |
| 4549 | 1619.4.1 | Deleted - Stage 2 for stand-alone L-GW and associated Mobility for LIPA and SIPTO at the Local Network | 519.85d? | 2010-10-22 A | 2012-12-12 A | 100% | 2010-10-22 | 2012-12-12 | 519.85d? | finish no earlier than 2012-12-12 | S2 | 4158.8h | 4158.8h | LIMONET-LIPA-del1 | 26 | Huawei | zhufenqin@huawei.com | Rel-12 | 50 | Maurice | PCG-30 | SP-58 |  | HNB |  |
| 4550 | 1619.4.2 | **Deleted - Stage 3 CN aspects of LIPA Mobility** | 323d? | 2011-09-24 A | 2012-12-12 A | 100% | 2011-09-24 | 2012-12-12 | 323d? |  | C1; C4 | 10336h | 10336h | LIMONET-LIPA-del2 | 27 | Huawei | christian.herrero@huawei.com | Rel-12 | 53 | Frederic | PCG-30 | SP-58 |  | HNB |  |
| 4551 | 1619.4.2.1 | Deleted - CT1 part of CN aspects of LIPA Mobility | 323d? | 2011-09-24 A | 2012-12-12 A | 100% | 2011-09-24 | 2012-12-12 | 323d? | finish no earlier than 2012-12-12 | C1 | 2584h | 2584h | LIMONET-LIPA-del3 | 27 | Huawei | christian.herrero@huawei.com | Rel-12 | 53 | Frederic | PCG-30 | SP-58 |  | HNB |  |
| 4552 | 1619.4.2.2 | Deleted - CT4 part of CN aspects of LIPA Mobility | 323d? | 2011-09-24 A | 2012-12-12 A | 100% | 2011-09-24 | 2012-12-12 | 323d? | finish no earlier than 2012-12-12 | C4 | 2584h | 2584h | LIMONET-LIPA-del4 | 27 | Huawei | christian.herrero@huawei.com | Rel-12 | 53 | Kimmo | PCG-30 | SP-58 |  | HNB |  |
| 4553 | 1620 | **Operator Policies for IP Interface Selection** | 720d? | 2011-03-23 A | 2013-12-06 A | 100% | 2011-03-23 | 2013-12-06 | 720d? |  | S2; C1 | 20256h | 20256h | OPIIS | 26 | LG Electronics | taehyeon.kim@lge.com | Rel-12 | 51 | Maurice |  |  | OPIIS |  |  |
| 4554 | 1620.1 | TR on Stage 2 for Operator Policies for IP Interface Selection | 457d? | 2011-03-23 A | 2012-12-12 A | 100% | 2011-03-23 | 2012-12-12 | 457d? | finish no earlier than 2012-12-12 | S2 | 3640h | 3640h | OPIIS | 26 | LG Electronics | taehyeon.kim@lge.com | Rel-12 | 51 | Maurice |  |  |  |  |  |
| 4555 | 1620.2 | Stage 2 for Operator Policies for IP Interface Selection | 511d? | 2011-04-04 A | 2013-03-06 A | 100% | 2011-04-04 | 2013-03-06 | 511d? | finish no earlier than 2013-03-06 | S2 | 4088h | 4088h | OPIIS | 26 | LG Electronics | taehyeon.kim@lge.com | Rel-12 | 51 | Maurice |  |  |  |  |  |
| 4556 | 1620.3 | Stage 3 for Operator Policies for IP Interface Selection | 126d? | 2013-06-14 A | 2013-12-06 A | 100% | 2013-06-14 | 2013-12-06 | 126d? | finish no earlier than 2013-12-06 | C1 | 1008h | 1008h | OPIIS-CT | 31 | LG Electronics | Jaehyun Kim (jaehyun7.kim@lge.com) | Rel-12 | 60 | Frederic |  |  | OPIIS-CT |  |  |
| 4557 | 1621 | **Short Message Service (SMS) submit and delivery without MSISDN in IMS** | 665d? | 2011-06-08 A | 2013-12-06 A | 100% | 2011-06-08 | 2013-12-06 | 665d? |  | S2; C1; C4 | 28336.3h | 28336.3h | SMSMI | 27 | Nokia Siemens Networks | curt.wong@nsn.com | Rel-12 | 52 | Maurice |  |  | SMSMI |  |  |
| 4558 | 1621.1 | TR on Stage 2 for SMS submit and delivery without MSISDN in IMS | 402d? | 2011-06-08 A | 2012-12-12 A | 100% | 2011-06-08 | 2012-12-12 | 402d? | finish no earlier than 2012-12-12 | S2 | 3192.32h | 3192.32h | SMSMI-SA2TR | 27 | Nokia Siemens Networks | curt.wong@nsn.com | Rel-12 | 52 | Maurice |  |  |  |  |  |
| 4559 | 1621.2 | Stage 2 for SMS submit and delivery without MSISDN in IMS | 400d? | 2011-06-13 A | 2012-12-12 A | 100% | 2011-06-13 | 2012-12-12 | 400d? | finish no earlier than 2012-12-12 | S2 | 3192h | 3192h | SMSMI-SA2 | 27 | Nokia Siemens Networks | curt.wong@nsn.com | Rel-12 | 52 | Maurice |  |  |  |  |  |

Notes:
- 4534: SP#60 stopped and Rel-13 FS_ACDC continues. Triggered by TR 22.806 Study on Application specific Congestion control for Data Communication (FS_ACDC) UID_570034 / Impacted TSs and TRs: Stage 1
- 4535: SP#60 stopped and Rel-13 FS_ACDC contd. Allow/prohibit for E-UTRAN idle mode UE initiation of particular applications defined by operator and subject to regional regulations. Prevent/mitigate overload of AN/CN defined by operator (congestion or disaster) / Impacted TSs and TRs: 22.011
- 4536: SP#59 Stage 1 completed / Impacted TSs and TRs: Stage 1
- 4537: SP#59 completed / Impacted TSs and TRs: 22.011
- 4538: -
- 4539: CP#63 completed. SP#58 updated WID SP-120256=>SP-120926 (stopped BB2 LIMONET-LIPA on Mobility). Linked to UID_450035 Local IP Access and Selected IP Traffic Offload (LIPA_SIPTO) / Impacted TSs and TRs: Stage 2/3
- 4540: SP#59 completed. TR 23.859 v100 for Information and Approval / Impacted TSs and TRs: new 23.859
- 4541: SP#60 completed / Impacted TSs and TRs: 23.060; 23.401
- 4542: SP#60 completed / Impacted TSs and TRs: 23.060; 23.401
- 4543: CP#63 completed / Impacted TSs and TRs: Stage 3
- 4544: CP#61 completed / Impacted TSs and TRs: 23.003; 23.008; 29.002; 29.060; 29.230; 29.272; 29.274; 29.303
- 4545: CP#63 completed / Impacted TSs and TRs: 24.008; 24.301
- 4546: - / Impacted TSs and TRs: UTRA; LTE
- 4547: RP#62 completed / Impacted TSs and TRs: 25.401; 25.413; 25.423; 25.467; 25.469; 36.300; 36.413; 36.423
- 4548: SP#58 updated WID SP-120256=>SP-120926 (stopped BB2 LIMONET-LIPA on Mobility) / Impacted TSs and TRs: 23.060; 23.401
- 4549: SP#58 updated WID SP-120256=>SP-120926 (stopped BB2 LIMONET-LIPA on Mobility) / Impacted TSs and TRs: 23.060; 23.401
- 4550: SP#58 CT Stage 3 part stopped because of SA stopping Stage 2 for BB2 LIMONET-LIPA on Mobility) / Impacted TSs and TRs: Stage 3
- 4551: SP#58 CT Stage 3 part stopped because of SA stopping Stage 2 for BB2 LIMONET-LIPA on Mobility) / Impacted TSs and TRs: 24.008; 24.301
- 4552: SP#58 CT Stage 3 part stopped because of SA stopping Stage 2 for BB2 LIMONET-LIPA on Mobility) / Impacted TSs and TRs: 29.060; 29.274; 29.281; 29.303; 29.002; 29.272; 29.275; 29.282; 29.305
- 4553: Linked to Rel-10 IFOM IP Flow Mobility and seamless WLAN offload (non-seamless WLAN offload aspects) & Rel-11 LIMONET (support traffic offload at local network) / Impacted TSs and TRs: Stage 2/3
- 4554: SP#58 completed / Impacted TSs and TRs: new 23.853
- 4555: SP#59 completed (23.402 CR#152: Introduction of Inter-APN Routing Policies) / Impacted TSs and TRs: 23.402
- 4556: CP#62 completed. Specify Inter-APN Routing Policies for selecting an IP interface to route IP flows among a choice of available interfacES in CP-150both 3GPP and non-3GPP accesses / Impacted TSs and TRs: 24.302; 24.312
- 4557: Linked to Rel-7 SMSIP (Support of SMS over generic 3GPP IP access), Rel-11 SIMTC, Rel-12 TR 22.988 SA1 Study on alternatives to E.164 for MTC / Impacted TSs and TRs: Stage 2/3
- 4558: SP#58 completed / Impacted TSs and TRs: new 23.863
- 4559: SP#58 completed / Impacted TSs and TRs: 23.204; 23.682

| ID | WBS | Task | Duration | Start | Finish | Complete | Baseline start | Baseline finish | Baseline duration | Constraint | Resources | Work | Actual work | Acronym | PCG approved | Impacted TSs and TRs | WI rapporteur name | WI rapporteur e-mail | Release | TSG approved | MCC resp | Acronym_3GU_Export | Status Report | Special Focus Doc |
| --- | --- | --- | --- | --- | --- | --- | --- | --- | --- | --- | --- | --- | --- | --- | --- | --- | --- | --- | --- | --- | --- | --- | --- | --- |
| 4560 | 1621.3 | **Stage 3 for SMS submit and delivery without MSISDN in IMS** | 205d? | 2013-03-01 A | 2013-12-06 A | 100% | 2013-03-01 | 2013-12-06 | 205d? |  | C1; C4 | 5992h | 5992h | SMSMI-CT | 30 | Stage 3 | NSN | peter.leis@nsn.com | Rel-12 | 59 | Frederic | SMSMI-CT |  |  |
| 4561 | 1621.3.1 | CT1 part of Stage 3 for SMS submit and delivery without MSISDN in IMS | 205d? | 2013-03-01 A | 2013-12-06 A | 100% | 2013-03-01 | 2013-12-06 | 205d? | finish no earlier than 2013-12-06 | C1 | 1608h | 1608h | SMSMI-CT | 30 | 23.040; 24.341 | NSN | peter.leis@nsn.com | Rel-12 | 59 | Frederic |  |  |  |
| 4562 | 1621.3.2 | CT4 part of Stage 3 for SMS submit and delivery without MSISDN in IMS | 139d? | 2013-03-01 A | 2013-09-06 A | 100% | 2013-03-01 | 2013-09-06 | 139d? | finish no earlier than 2013-09-06 | C4 | 1104h | 1104h | SMSMI-CT | 30 | 23.008; 29.002; 29.305; 29.328; 29.338 | NSN | peter.leis@nsn.com | Rel-12 | 59 | Kimmo |  |  |  |
| 4563 | 1622 | **IMS-based Telepresence** | 1247.5d? | 2010-03-22 A | 2014-12-09 A | 100% | 2010-03-19 | 2014-12-05 | 1243.5d? |  | S1; C1; C3; C4; IETF | 122882h | 122882h | IMS_TELEP | 27 | Stage 1/2/3 | Orange | bruno.tossou@orange-ftgroup.com | Rel-12 | 53 | Alain | IMS_TELEP |  |  |
| 4564 | 1622.1 | Stage 1 for IMS-based Telepresence | 197d? | 2011-09-22 A | 2012-06-20 A | 100% | 2011-09-22 | 2012-06-20 | 197d? | finish no earlier than 2012-06-08 | S1 | 1569.86h | 1569.86h | IMS_TELEP | 27 | 22.228 | Orange | bruno.tossou@orange-ftgroup.com | Rel-12 | 53 | Alain |  |  |  |
| 4565 | 1622.2 | **CT part for IMS Telepresence (Stage 2/3)** | 1247.5d? | 2010-03-22 A | 2014-12-09 A | 100% | 2010-03-19 | 2014-12-05 | 1243.5d? |  | C1; C3; C4; IETF | 87712h | 87712h | IMS_TELEP | 30 | Stage 2/3 | Huawei | Weiwei(Tommy) Yang (tommy@huawei.com) | Rel-12 | 58 | Frederic |  |  |  |
| 4566 | 1622.2.1 | TR on CT part of IMS Telepresence (Stage 2/3) | 399d? | 2012-12-07 A | 2014-06-13 A | 100% | 2012-12-07 | 2014-06-13 | 399d? | finish no earlier than 2014-06-13 | C1 | 3184h | 3184h | IMS_TELEP | 30 | New 24.803 | Huawei | Weiwei(Tommy) Yang (tommy@huawei.com) | Rel-12 | 58 | Frederic |  |  |  |
| 4567 | 1622.2.2 | CT1 part of IMS Telepresence (Stage 3) | 526d? | 2012-12-07 A | 2014-12-09 A | 100% | 2012-12-07 | 2014-09-12 | 464d? | finish no earlier than 2014-12-09 | C1 | 4208h | 4208h | IMS_TELEP | 30 | 24.147; 24.166; 24.229; New 24.103 | Huawei | Weiwei(Tommy) Yang (tommy@huawei.com) | Rel-12 | 58 | Frederic |  | CP-140616 |  |
| 4568 | 1622.2.3 | (IETF) Session Description Protocol (SDP) Offer/Answer Procedures For Stream Control Transmission Protocol (SCTP) over Datagram Transport Layer Security (DTLS) | 851d? | 2010-03-22 A | 2014-12-05 A | 100% | 2010-03-19 | 2014-12-05 | 849d? | finish no earlier than 2014-12-09 | C1-IETF | 6808h | 6808h | IMS_TELEP | 33 | draft-ietf-mmusic-sctp-sdp; RFC 8842 | christer.holmberg@ericsson.com | christer.holmberg@ericsson.com | Rel-12 | 64 |  |  |  |  |
| 4569 | 1622.2.4 | (IETF) Framework for Telepresence Multi-Streams (draft-ietf-clue-framework) | 851d? | 2010-03-22 A | 2014-12-05 A | 100% | 2010-03-19 | 2014-12-05 | 849d? | finish no earlier than 2014-12-09 | C1-IETF | 6808h | 6808h | IMS_TELEP | 33 | draft-ietf-clue-framework; RFC 8845 | christer.holmberg@ericsson.com | christer.holmberg@ericsson.com | Rel-12 | 64 |  |  |  |  |
| 4570 | 1622.2.5 | (IETF) CLUE Protocol data channel (draft-ietf-clue-datachannel) | 851d? | 2010-03-22 A | 2014-12-05 A | 100% | 2010-03-19 | 2014-12-05 | 849d? | finish no earlier than 2014-12-09 | C1-IETF | 6808h | 6808h | IMS_TELEP | 33 | draft-ietf-clue-datachannel; RFC 8850 | christer.holmberg@ericsson.com | christer.holmberg@ericsson.com | Rel-12 | 64 |  |  |  |  |
| 4571 | 1622.2.6 | (IETF) Session Signaling for Controlling Multiple Streams for Telepresence (CLUE) (draft-ietf-clue-signaling) | 851d? | 2010-03-22 A | 2014-12-05 A | 100% | 2010-03-19 | 2014-12-05 | 849d? | finish no earlier than 2014-12-09 | C1-IETF | 6808h | 6808h | IMS_TELEP | 33 | draft-ietf-clue-signaling; RFC 8848 | christer.holmberg@ericsson.com | christer.holmberg@ericsson.com | Rel-12 | 64 |  |  |  |  |
| 4572 | 1622.2.7 | (IETF) An XML Schema for the CLUE data model (draft-ietf-clue-data-model-schema) | 851d? | 2010-03-22 A | 2014-12-05 A | 100% | 2010-03-19 | 2014-12-05 | 849d? | finish no earlier than 2014-12-09 | C1-IETF | 6808h | 6808h | IMS_TELEP | 33 | draft-ietf-clue-data-model-schema; RFC 8846 | christer.holmberg@ericsson.com | christer.holmberg@ericsson.com | Rel-12 | 64 |  |  |  |  |
| 4573 | 1622.2.8 | CT3 part of IMS Telepresence (Stage 3) | 467d? | 2012-12-07 A | 2014-09-11 A | 100% | 2012-12-07 | 2014-09-12 | 467d? | finish no earlier than 2014-09-12 | C3 | 3736h | 3736h | IMS_TELEP | 30 | 29.165 | Huawei | Weiwei(Tommy) Yang (tommy@huawei.com) | Rel-12 | 58 | Adrian |  |  |  |
| 4574 | 1622.2.9 | CT4 part of IMS Telepresence (Stage 2/3) | 328d? | 2013-09-13 A | 2014-12-09 A | 100% | 2013-09-10 | 2014-09-12 | 266d? | finish no earlier than 2014-12-09 | C4 | 2624h | 2624h | IMS_TELEP | 31 | 23.333; 29.333 | Huawei | Weiwei(Tommy) Yang (tommy@huawei.com) | Rel-12 | 61 | Kimmo |  | CP-140477 |  |
| 4575 | 1623 | **Group Communication System Enablers for LTE** | 727d? | 2012-06-18 A | 2015-03-13 A | 100% | 2012-06-18 | 2014-09-17 | 597d? |  | S1; S2; S3; C3; C4; R3; C1 | 58696h | 58696h | GCSE_LTE | 29 | Stage 1/2/3 | Nokia Networks | Juergen.Merkel@nsn.com | Rel-12 | 56 | Alain | GCSE_LTE |  | Public Safety (A-A) |
| 4576 | 1623.1 | Stage 1 for Group Communication System Enablers for LTE | 267d? | 2012-06-18 A | 2013-06-19 A | 100% | 2012-06-18 | 2013-06-19 | 267d? | finish no earlier than 2013-06-19 | S1 | 2128h | 2128h | GCSE_LTE | 29 | New 22.468 | Nokia Networks | Juergen.Merkel@nsn.com | Rel-12 | 56 | Alain |  |  | Public Safety (A-A) |
| 4577 | 1623.2 | TR on Architecture enhancements to support Group Communication System Enablers for LTE | 267d? | 2013-03-07 A | 2014-03-07 A | 100% | 2013-03-07 | 2014-03-07 | 267d? | finish no earlier than 2014-03-07 | S2 | 2128h | 2128h | GCSE_LTE | 30 | New 23.768 | Nokia Networks | rainer.liebhart@nsn.com | Rel-12 | 59 | Maurice |  |  | Public Safety (A-A) |
| 4578 | 1623.3 | Stage 2 for Group Communication System Enablers for LTE | 402d? | 2013-03-12 A | 2014-09-16 A | 100% | 2013-03-12 | 2014-09-17 | 402d? | finish no earlier than 2014-09-17 | S2 | 3208h | 3208h | GCSE_LTE | 30 | New 23.468 | Nokia Networks | rainer.liebhart@nsn.com | Rel-12 | 59 | Maurice |  |  | Public Safety (A-A) |
| 4579 | 1623.4 | TR on Security for Group Communication System Enablers for LTE (Stage 2) | 201d? | 2013-09-12 A | 2014-06-18 A | 100% | 2013-09-12 | 2014-06-18 | 201d? | finish no earlier than 2014-06-18 | S3 | 1608h | 1608h | GCSE_LTE | 31 | New 33.888 | Nokia Networks | anja.jerichow@nsn.com | Rel-12 | 61 | Mirko |  |  | Public Safety (A-A) |
| 4580 | 1623.5 | Security for Group Communication System Enablers for LTE (Stage 2) | 201d? | 2013-09-13 A | 2014-06-18 A | 100% | 2013-09-13 | 2014-06-18 | 201d? | finish no earlier than 2014-06-18 | S3 | 1608h | 1608h | GCSE_LTE | 31 | 33.246 | Nokia Networks | anja.jerichow@nsn.com | Rel-12 | 61 | Mirko |  |  | Public Safety (A-A) |
| 4581 | 1623.6 | **CT aspects of Group Communication System Enablers for LTE** | 131d? | 2014-06-13 A | 2014-12-09 A | 100% | 2014-06-13 | 2014-09-12 | 66d? |  | C3; C4; C1 | 4152h | 4152h | GCSE_LTE-CT | 33 | Stage 3 | Nokia Networks | thomas.belling@nsn.com | Rel-12 | 64 |  | GCSE_LTE-CT |  | Public Safety (A-A) |
| 4582 | 1623.6.1 | CT3 part of Group Communication System Enablers for LTE | 66d? | 2014-06-13 A | 2014-09-11 A | 100% | 2014-06-13 | 2014-09-12 | 66d? | finish no earlier than 2014-09-12 | C3 | 528h | 528h | GCSE_LTE-CT | 33 | 29.212; 29.213; 29.214; 29.274; New 29.468 | Nokia Networks | thomas.belling@nsn.com | Rel-12 | 64 |  |  |  | Public Safety (A-A) |
| 4583 | 1623.6.2 | CT4 part of Group Communication System Enablers for LTE | 128d? | 2014-06-13 A | 2014-12-09 A | 100% | 2014-06-13 | 2014-09-12 | 66d? | finish no earlier than 2014-12-09 | C4 | 1024h | 1024h | GCSE_LTE-CT | 33 | 23.007; 23.008 | Nokia Networks | thomas.belling@nsn.com | Rel-12 | 64 |  |  | CP-140725 | Public Safety (A-A) |
| 4584 | 1623.6.3 | CT1 part of Group Communication System Enablers for LTE | 63d? | 2014-09-12 A | 2014-12-09 A | 100% |  |  |  | finish no earlier than 2014-12-09 | C1 | 504h | 504h | GCSE_LTE-CT | 33 | 24.301 | Nokia Networks | thomas.belling@nsn.com | Rel-12 | 65 |  |  | CP-140614 | Public Safety (A-A) |

Notes:
- 4560: CP#62 completed. Address scenario IMS client to IMS client SMS (comprises SMS receive and send SMS without requiring an MSISDN associated as part of their subscription record in HSS
- 4561: CP#62 completed
- 4562: CP#61 completed
- 4563: This feature does not introduce any changes to the IMS architecture, and no stage 2 impacts are identified
- 4564: SP#56 completed. 2/4/15: acronym changed to IMS_TELEP
- 4565: CP#65 updated WID CP-140196=>CP-140624. 2/4/15: acronym changed to IMS_TELEP
- 4566: CP#64 completed. 2/4/15: acronym changed to IMS_TELEP
- 4567: CP#65 TS 24.103v100 for Information. Updated WID CP-140196=>CP-140624. Completion 09/14=>12/14. Exception in CP-140616. Dec.14: 90->100%. 2/4/15: acronym changed to IMS_TELEP
- 4568: work in progress. 2/4/15: acronym changed to IMS_TELEP. Was (IETF) CT1 part of IMS Telepresence (draft-ietf-mmusic-sctp-sdp).; 23/4/20: 50%->90; 9/4/21: RFC 8842 added;
- 4569: work in progress. 2/4/15: acronym changed to IMS_TELEP; 23/4/20: 50%->90. Was (IETF) CT1 part of IMS Telepresence (draft-ietf-clue-framework ); 9/4/21: RFC 8845 added;
- 4570: work in progress. 2/4/15: acronym changed to IMS_TELEP; 23/4/20: 50%->90. Was (IETF) CT1 part of IMS Telepresence (draft-ietf-clue-datachannel); 9/4/21: RFC 8850 added;
- 4571: work in progress. 2/4/15: acronym changed to IMS_TELEP; 23/4/20: 50%->90. Was (IETF) CT1 part of IMS Telepresence (draft-ietf-clue-signaling); 9/4/21: RFC 8848 added;
- 4572: work in progress. 2/4/15: acronym changed to IMS_TELEP; 23/4/20: 50%->90. Was (IETF) CT1 part of IMS Telepresence (draft-ietf-clue-data-model-schema); 9/4/21: RFC 8846 added;
- 4573: CP#65 completed. 2/4/15: acronym changed to IMS_TELEP
- 4574: CP#65 updated WID CP-140196=>CP-140624. Completion 09/14=>12/14. Exception in CP-140477. Mar.15: 0->100%. 2/4/15: acronym changed to IMS_TELEP
- 4575: Linked to Rel-12 FS_ProSe TR 22.803 Study on Proximity-based Services. External requirements: NIST, MESA, APCO Global Alliance, TCCA. Specify 3GPP system enablers to support group communication over LTE for Public Safety
- 4576: SP#60 completed. TS 22.468 v100 for 1-step Approval
- 4577: SP#63 completed. TR 23.768v200 for Approval
- 4578: SP#65 completed. Updated WID SP-140113=>SP-140433. SP#63 TS 23.468v100 for 1-step Approval
- 4579: SP#64 completed. TR 33.888v100 for 1-step Approval
- 4580: SP#64 completed
- 4581: CP#65 updated WID CP-140452=>C3-143199 (added CT1 part)
- 4582: CP#65 completed. TS 29.468v200 for Approval
- 4583: CP#65 completion 09/14=>12/14. Exception in CP-140725. Dec.14: 35->100
- 4584: CP#65 updated WID CP-140452=>CP-140559 (added CT1 part). Exception in CP-140614. Dec.14: 90->100%

| ID | WBS | Task | Duration | Start | Finish | Complete | Remaining | Baseline start | Baseline finish | Baseline duration | Total slack | Constraint | Resources | Work | Actual work | Acronym | PCG approved | Impacted TSs and TRs | WI rapporteur name | WI rapporteur e-mail | Release | TSG approved | Special Focus Doc | Acronym_3GU_Export | Status Report | MCC resp | PCG stopped | TSG stopped |
| --- | --- | --- | --- | --- | --- | --- | --- | --- | --- | --- | --- | --- | --- | --- | --- | --- | --- | --- | --- | --- | --- | --- | --- | --- | --- | --- | --- | --- |
| 4585 | 1623.7 | **Group Call eMBMS congestion management for LTE** | 198d? | 2014-06-16 A | 2015-03-13 A | 100% |  | 2014-06-13 | 2014-09-12 | 66d? |  |  | R3 | 3152h | 3152h | GCSE_LTE-MBMS_CM | 33 | LTE | Alcatel-Lucent | hakon.helmers@alcatel-lucent.com | Rel-12 | 64 | Public Safety (A-A) | GCSE_LTE-MBMS_CM |  |  |  |  |
| 4586 | 1623.7.1 | Core part: Group Call eMBMS congestion management for LTE | 196d? | 2014-06-16 A | 2015-03-13 A | 100% |  | 2014-06-13 | 2014-09-12 | 66d? |  | finish no earlier than 2015-03-15 | R3 | 1568h | 1568h | GCSE_LTE-MBMS_CM-Core | 33 | 36.413 | Alcatel-Lucent | hakon.helmers@alcatel-lucent.com | Rel-12 | 64 | Public Safety (A-A) | GCSE_LTE-MBMS_CM-Core | RP-150081 |  |  |  |
| 4587 | 1624 | **Machine-Type and other mobile data applications Communications enhancements** | 1692d? | 2009-12-10 A | 2016-05-12 | 98% | 40.3d? | 2009-12-10 | 2014-09-12 | 1255d? | 2563d |  |  | 58859h | 57908.6h | MTCe | 29 | Stage 1/2/3 | Intel | puneet.jain@intel.com | Rel-12 | 56 | MTC, M2M | MTCe |  | Maurice |  |  |
| 4588 | 1624.1 | Stage 1 for Support for Interworking with M2M Service Enablement | 189d? | 2012-06-18 A | 2013-03-06 A | 100% |  | 2012-06-18 | 2013-03-06 | 189d? |  | finish no earlier than 2013-03-06 | S1 | 1504h | 1504h | MTCe-SIMSE | 29 | 22.368 | KPN | toon.norp@tno.nl | Rel-12 | 56 | MTC, M2M | MTCe-SIMSE |  | Alain |  |  |
| 4589 | 1624.2 | Stage 1 for Machine-Type and other mobile data applications Communications – Service Requirement Maintenance | 127d? | 2012-09-13 A | 2013-03-06 A | 100% |  | 2012-09-13 | 2013-03-06 | 127d? |  | finish no earlier than 2013-03-06 | S1 | 1008h | 1008h | MTCe-SRM | 29 | 22.101; 22.368 | KPN | toon.norp@tno.nl | Rel-12 | 57 | MTC, M2M | MTCe-SRM |  | Alain |  |  |
| 4590 | 1624.3 | TR on Security aspects of Machine-Type Communications | 1113d? | 2009-12-10 A | 2014-03-07 A | 100% |  | 2009-12-10 | 2014-03-07 | 1113d? |  | finish no earlier than 2014-03-07 | S3 | 8896h | 8896h | MTCe-SA3TR | 29 | New 33.868 | Samsung | Rajavelsamy R (rajvel@samsung.com) | Rel-12 | 56 | MTC, M2M |  |  | Mirko |  |  |
| 4591 | 1624.4 | Security and Privacy aspects for Machine-Type and other mobile data applications Communications enhancements (Stage 2) | 452d? | 2012-06-22 A | 2014-03-07 A | 100% |  | 2012-06-22 | 2014-03-07 | 452d? |  | finish no earlier than 2014-03-07 | S3 | 3608h | 3608h | MTCe-SA3 | 29 | New 33.187 | Samsung | Rajavelsamy R (rajvel@samsung.com) | Rel-12 | 56 | MTC, M2M |  |  | Mirko |  |  |
| 4592 | 1624.5 | **BB1: Small Data and Device Triggering Enhancements (SDDTE)** | 594d? | 2012-06-18 A | 2014-09-11 A | 100% |  | 2012-06-18 | 2014-09-12 | 594d? |  |  | S2; C4; C3 | 24400h | 24400h | MTCe-SDDTE | 29 |  | Intel | puneet.jain@intel.com | Rel-12 | 56 | MTC, M2M | MTCe-SDDTE |  | Maurice |  |  |
| 4593 | 1624.5.1 | TR on Stage 2 BB1: Small Data and Device Triggering Enhancements | 394d? | 2012-06-18 A | 2013-12-11 A | 100% |  | 2012-06-18 | 2013-12-11 | 394d? |  | finish no earlier than 2013-12-11 | S2 | 3128h | 3128h | MTCe-SDDTE | 29 | New 23.887 | Intel | puneet.jain@intel.com | Rel-12 | 56 | MTC, M2M |  |  | Maurice |  |  |
| 4594 | 1624.5.2 | Stage 2 for BB1: Small Data and Device Triggering Enhancements | 390d? | 2012-06-26 A | 2013-12-11 A | 100% |  | 2012-06-26 | 2013-12-11 | 390d? |  | finish no earlier than 2013-12-11 | S2 | 3120h | 3120h | MTCe-SDDTE | 29 | 23.682 | Intel | puneet.jain@intel.com | Rel-12 | 56 | MTC, M2M |  |  | Maurice |  |  |
| 4595 | 1624.5.3 | **Stage 3 for BB1: Small Data and Device Triggering Enhancements** | 138d? | 2014-03-05 A | 2014-09-11 A | 100% |  | 2014-03-05 | 2014-09-12 | 138d? |  |  | C4; C3 | 3896h | 3896h | MTCe-SDDTE-CT | 32 | Stage 3 | Huawei | peter.schmitt@huawei.com | Rel-12 | 63 | MTC, M2M | MTCe-SDDTE-CT |  | Kimmo |  |  |
| 4596 | 1624.5.3.1 | CT4 part of Stage 3 for BB1: Small Data and Device Triggering Enhancement | 138d? | 2014-03-05 A | 2014-09-11 A | 100% |  | 2014-03-05 | 2014-09-12 | 138d? |  | finish no earlier than 2014-09-12 | C4 | 1104h | 1104h | MTCe-SDDTE-CT | 32 | 29.002; 29.336; 23.008; 29.337; 29.338; 29.230 | Huawei | peter.schmitt@huawei.com | Rel-12 | 63 | MTC, M2M |  |  | Kimmo |  |  |
| 4597 | 1624.5.3.2 | CT3 part of Stage 3 for BB1: Small Data and Device Triggering Enhancement | 73d? | 2014-03-05 A | 2014-06-13 A | 100% |  | 2014-03-05 | 2014-06-13 | 73d? |  | finish no earlier than 2014-06-13 | C3 | 584h | 584h | MTCe-SDDTE-CT | 32 | 29.368 | Huawei | peter.schmitt@huawei.com | Rel-12 | 63 | MTC, M2M |  |  | Adrian |  |  |
| 4598 | 1624.6 | Deleted - BB2: Monitoring Enhancements (MONTE) | 131d? | 2012-06-18 A | 2012-12-12 A | 100% |  | 2012-06-18 | 2012-12-12 | 131d? |  | finish no earlier than 2012-12-12 | S2 | 1048h | 1048h | MTCe-MONTE | 29 | 23.682 | Intel | puneet.jain@intel.com | Rel-12 | 56 | MTC, M2M | MTCe-MONTE |  | Maurice | PCG-30 | SP-58 |
| 4599 | 1624.7 | **BB3: UE Power Consumptions Optimizations (UEPCOP)** | 1031d? | 2012-06-18 A | 2016-05-12 | 93% | 71.29d? | 2012-06-18 | 2014-09-12 | 594d? | 2563d |  |  | 13712h | 12761.6h | MTCe-UEPCOP | 29 |  | Ericsson | peter.hedman@ericsson.com | Rel-12 | 56 | MTC, M2M | MTCe-UEPCOP |  | Maurice |  |  |
| 4600 | 1624.7.1 | TR on Stage 2 BB3: UE Power Consumptions Optimizations (UEPCOP) | 394d? | 2012-06-18 A | 2013-12-11 A | 100% |  | 2012-06-18 | 2013-12-11 | 394d? |  | finish no earlier than 2013-12-11 | S2 | 3128h | 3128h | MTCe-UEPCOP | 29 | New 23.887 | Ericsson | peter.hedman@ericsson.com | Rel-12 | 56 | MTC, M2M |  |  | Maurice |  |  |
| 4601 | 1624.7.2 | Stage 2 for BB3: UE Power Consumptions Optimizations (UEPCOP) | 390d? | 2012-06-26 A | 2013-12-11 A | 100% |  | 2012-06-26 | 2013-12-11 | 390d? |  | finish no earlier than 2013-12-11 | S2 | 3120h | 3120h | MTCe-UEPCOP | 29 | 23.060; 23.401; 23.682 | Ericsson | peter.hedman@ericsson.com | Rel-12 | 56 | MTC, M2M |  |  | Maurice |  |  |
| 4602 | 1624.7.3 | **Stage 3 for BB3: UE Power Consumptions Optimizations (UEPCOP)** | 597d? | 2013-12-06 A | 2016-03-15 A | 100% |  | 2013-12-06 | 2014-09-12 | 202d? |  |  |  | 6368h | 6368h | MTCe-UEPCOP-CT | 32 | Stage 3 | Ericsson | mikael.wass@ericsson.com | Rel-12 | 62 | MTC, M2M | MTCe-UEPCOP-CT |  | Frederic |  |  |
| 4603 | 1624.7.3.1 | CT1 part of Stage 3 for BB3: UE Power Consumptions Optimizations (UEPCOP) | 202d? | 2013-12-06 A | 2014-09-11 A | 100% |  | 2013-12-06 | 2014-09-12 | 202d? |  | finish no earlier than 2014-09-12 | C1 | 1608h | 1608h | MTCe-UEPCOP-CT1 | 32 | 24.008; 24.301 | Ericsson | mikael.wass@ericsson.com | Rel-12 | 62 | MTC, M2M |  |  | Frederic |  |  |
| 4604 | 1624.7.3.2 | Deleted - CT4 part of Stage 3 for BB3: UE Power Consumptions Optimizations (UEPCOP) | 201d? | 2013-12-09 A | 2014-09-11 A | 100% |  | 2013-12-09 | 2014-09-12 | 201d? |  | finish no earlier than 2014-09-12 | C4 | 1608h | 1608h | MTCe-UEPCOP-CT4 | 32 | 29.274; 29.060; 23.008 | Ericsson | mikael.wass@ericsson.com | Rel-12 | 62 | MTC, M2M |  |  | Kimmo | PCG-33 | CP-65 |
| 4605 | 1624.7.3.3 | CT6 part of Stage 3 for BB3: UE Power Consumptions Optimizations (UEPCOP) | 263d? | 2013-12-09 A | 2014-12-09 A | 100% |  | 2013-12-09 | 2014-09-12 | 201d? |  | finish no earlier than 2014-12-09 | C6 | 2104h | 2104h | MTCe-UEPCOP-CT6 | 32 | 31.101; 31.102; 31.111 | Ericsson | mikael.wass@ericsson.com | Rel-12 | 62 | MTC, M2M |  | CP-140697 | Xavier |  |  |
| 4606 | 1624.7.3.4 | UE Conformance Test Aspects - UE Power Consumptions Optimizations (UEPCOP) | 131d? | 2015-09-15 A | 2016-03-15 A | 100% |  |  |  |  |  | finish no earlier than 2016-03-15 | R5 | 1048h | 1048h | MTCe-UEPCOP-UEConTest | 35 |  | Ericsson |  | Rel-12 | 69 |  |  |  |  |  |  |
| 4607 | 1624.7.4 | Support of Power Saving Mode in GERAN | 5d? | 2014-08-25 A | 2014-08-29 A | 100% |  |  |  |  |  | finish no earlier than 2014-08-29 | G1 | 40h | 40h | MTCe-UEPCOP-GERAN | 33 | 43.022 | Ericsson | sajal.kumar.das@ericsson.com | Rel-12 | 63 |  | MTCe-UEPCOP-GERAN |  |  |  |  |
| 4608 | 1624.7.5 | Testing of Support of Power Saving Mode in GERAN | 132d? | 2015-11-11 A | 2016-05-12 | 10% | 118.8d? |  |  |  | 2563d | finish no earlier than 2016-05-12 | G3 | 1056h | 105.6h | MTCe-UEPCOP_GERAN3new | 36 |  | Ericsson | sajal.kumar.das@ericsson.com | Rel-12 | 70 |  | MTCe-UEPCOP-GERAN |  |  |  |  |
| 4609 | 1624.8 | Deleted - BB4: Group based MTC feature (GROUP) | 129d? | 2012-06-20 A | 2012-12-12 A | 100% |  | 2012-06-20 | 2012-12-12 | 129d? |  | finish no earlier than 2012-12-12 | S2 | 1032h | 1032h | MTCe-GROUP | 29 | 23.682 | KPN | Annemieke Kips | Rel-12 | 56 | MTC, M2M | MTCe-GROUP |  | Maurice | PCG-30 | SP-58 |

Notes:
- 4585: -
- 4586: CD:Thu 11/12/14->Sun 15/03/15¦Compl:25%->80%¦Stat Rep: RP-141327->RP-141863 1st Apr 15: Compl:80%->100% 1st Apr 15: Stat Rep: RP-141863->RP-150081
- 4587: -
- 4588: SP#59 completed. Define requirements for interworking with M2M service enablement layer specified by ETSI TC M2M in TS 102 689 ( specification for Service Enablement layer)
- 4589: SP#59 completed. Updated WID SP-120541=>SP-130105
- 4590: SP#63 completed. TR 33.868v100 for 1-step Approval. Was Rel-10 UID_460023 (Security for NIMTC). Was Rel-11 UID_490028 (TR on Security aspects of MTC). SP#56 activity transferred to Rel-12 Feature MTCe
- 4591: SP#63 completed. TS 33.187v100 for 1-step Approval
- 4592: -
- 4593: SP#62 completed. TR 23.887v200 for Approval
- 4594: SP#62 completed
- 4595: CP#65 updated WID CP-140272=>CP-140489
- 4596: CP#65 completed. Updated WID CP-140272=>CP-140489
- 4597: CP#64 completed
- 4598: SP#58 stopped (at 20% completion)
- 4599: -
- 4600: SP#62 completed. TR 23.887v200 for Approval
- 4601: SP#62 completed
- 4602: -
- 4603: CP#65 completed
- 4604: CP#65 stopped (no inpact on CT4)
- 4605: CP#65 completion 09/14=>12/14. Exception in CP-140697¦June2015: Compl:90%->100
- 4606: tested: MTCe-UEPCOP was a REL-12 SA2 WI¦NAS over LTE and UTRA;1/1/16: Compl:0%->25%22/3/16: C
- 4607: GP#63 approved WID and completed
- 4608: 7/12/15: created.02/3/16: acronym: MTCe-UEPCOP-GERAN_test->MTCe-UEPCOP_GERAN3new¦2/3/16: 0%->10
- 4609: SP#58 stopped (at 25% completion)

| ID | WBS | Task | Duration | Start | Finish | Complete | Baseline start | Baseline finish | Baseline duration | Constraint | Resources | Work | Actual work | Acronym | PCG approved | WI rapporteur name | WI rapporteur e-mail | Release | TSG approved | MCC resp | Special Focus Doc | Acronym_3GU_Export | Status Report | PCG stopped | TSG stopped |
| --- | --- | --- | --- | --- | --- | --- | --- | --- | --- | --- | --- | --- | --- | --- | --- | --- | --- | --- | --- | --- | --- | --- | --- | --- | --- |
| 4610 | 1624.9 | **RAN enhancements for Machine-Type and other mobile data applications Communications** | 161.2d? | 2014-02-03 A | 2014-09-12 A | 100% | 2014-02-03 | 2014-09-12 | 160.2d? |  | R2; R3 | 3651h | 3651h | MTCe-RAN | 32 | ZTE | sergio.parolari@zte.com.cn | Rel-12 | 62 | Yong-Jun | MTC, M2M | MTCe-RAN |  |  |  |
| 4611 | 1624.9.1 | Core part: RAN enhancements for Machine-Type and other mobile data applications Communications | 133d? | 2014-02-03 A | 2014-09-12 A | 100% | 2014-02-03 | 2014-09-12 | 133d? | finish no earlier than 2014-09-12 | R2; R3 | 2128h | 2128h | MTCe-RAN-Core | 32 | ZTE | sergio.parolari@zte.com.cn | Rel-12 | 62 | Yong-Jun | MTC, M2M | MTCe-RAN-Core | RP-141096 |  |  |
| 4612 | 1625 | **Low cost & enhanced coverage MTC UE for LTE** | 922d? | 2013-06-15 A | 2016-12-15 A | 100% | 2013-06-20 | 2015-03-13 | 456d? |  | R1; R2; R4 | 34104h | 34104h | LC_MTC_LTE | 31 | Vodafone | eric.bouton@vodafone.com | Rel-12 | 60 | Patrick | MTC, M2M | LC_MTC_LTE |  |  |  |
| 4613 | 1625.1 | Core part: Low cost & enhanced coverage MTC UE for LTE | 174.67d? | 2013-06-15 A | 2014-12-15 A | 100% | 2013-10-15 | 2014-09-12 | 108.67d? | finish no earlier than 2014-12-15 | R1; R2; R4 | 4192h | 4192h | LC_MTC_LTE-Core | 31 | Vodafone | eric.bouton@vodafone.com | Rel-12 | 60 | Patrick | MTC, M2M | LC_MTC_LTE-Core | RP-142024 |  |  |
| 4614 | 1625.2 | Perf. part: Low cost & enhanced coverage MTC UE for LTE | 522d? | 2013-06-15 A | 2015-06-15 A | 100% | 2013-06-20 | 2015-03-13 | 456d? | finish no earlier than 2015-06-15 | R4 | 4176h | 4176h | LC_MTC_LTE-Perf | 31 | Vodafone | eric.bouton@vodafone.com | Rel-12 | 60 | Issam | MTC, M2M | LC_MTC_LTE-Perf | RP-150915 |  |  |
| 4615 | 1625.3 | UE Conformance Test Aspects - Low cost & enhanced coverage MTC UE for LTE | 460d? | 2015-03-16 A | 2016-12-15 A | 100% |  |  |  | finish no earlier than 2016-12-15 | R5 | 3680h | 3680h | LC_MTC_LTE-UEConTest | 34 | Ericsson |  | Rel-12 | 67 |  |  |  |  |  |  |
| 4616 | 1626 | **Policy and Charging Control for supporting fixed broadband access networks** | 660d? | 2012-06-20 A | 2014-12-12 A | 100% | 2012-06-20 | 2014-09-17 | 595d? |  | S2; S1; S5; C3; C1; C4 | 84075.4h | 84075.4h | P4C | 29 | Huawei | marco.spini@huawei.com | Rel-12 | 56 | Maurice |  | P4C |  |  |  |
| 4617 | 1626.1 | Stage 1 for Policy and Charging Support for Fixed Mobile Convergence | 3d? | 2012-09-10 A | 2012-09-12 A | 100% | 2012-09-10 | 2012-09-12 | 3d? | finish no earlier than 2012-09-12 | S1 | 24h | 24h | P4C-FMC | 29 | Huawei | amar.deol@huawei.com | Rel-12 | 57 | Alain |  | P4C-FMC |  |  |  |
| 4618 | 1626.2 | **BB1: Policy and Charging Control for supporting traffic from fixed terminals and NSWO (Non Seamless WLAN Offload) traffic from 3GPP UEs in fixed broadband access networks (P4C-F)** | 660d? | 2012-06-20 A | 2014-12-12 A | 100% | 2012-06-20 | 2014-09-17 | 595d? |  | S2; S5; C3; C1; C4 | 45657.3h | 45657.3h | P4C-F | 29 | Huawei | marco.spini@huawei.com | Rel-12 | 56 | Maurice | WLAN | P4C-F |  |  |  |
| 4619 | 1626.2.1 | TR on Stage 2 for BB1: Policy and Charging Control for supporting traffic from fixed terminals and NSWO traffic from 3GPP UEs in fixed broadband access networks (P4C-F) | 539.9d? | 2012-06-20 A | 2014-12-12 A | 100% | 2012-06-20 | 2014-09-17 | 476.9d? | finish no earlier than 2014-12-12 | S2 | 4290.1h | 4290.1h | P4C-F-SA2TR | 29 | Huawei | marco.spini@huawei.com | Rel-12 | 56 | Maurice | WLAN |  |  |  |  |
| 4620 | 1626.2.2 | Stage 2 for BB1: Policy and Charging Control for supporting traffic from fixed terminals and NSWO traffic from 3GPP UEs in fixed broadband access networks (P4C-F) | 272.9d? | 2012-06-20 A | 2013-12-11 A | 100% | 2012-06-20 | 2013-12-11 | 272.9d? | finish no earlier than 2013-12-11 | S2 | 2183.2h | 2183.2h | P4C-F-SA2 | 29 | Huawei | marco.spini@huawei.com | Rel-12 | 56 | Maurice | WLAN |  |  |  |  |
| 4621 | 1626.2.3 | **Stage 3 for BB1: Policy and Charging Control for supporting traffic from fixed terminals and NSWO traffic from 3GPP UEs in fixed broadband access networks** | 203d? | 2013-09-06 A | 2014-06-13 A | 100% | 2013-09-06 | 2014-06-13 | 203d? |  | C3; C1; C4 | 8088h | 8088h | P4C-F-CT3 | 31 | Huawei | Xia Haitao (xiahaitao@huawei.com) | Rel-12 | 61 | Adrian | WLAN | P4C-F-CT3 |  |  |  |
| 4622 | 1626.2.3.1 | CT3 part of Stage 3 for BB1: Policy and Charging Control for supporting traffic from fixed terminals and NSWO traffic from 3GPP UEs in fixed broadband access networks | 203d? | 2013-09-06 A | 2014-06-13 A | 100% | 2013-09-06 | 2014-06-13 | 203d? | finish no earlier than 2014-06-13 | C3 | 1608h | 1608h | P4C-F-CT3 | 31 | Huawei | Xia Haitao (xiahaitao@huawei.com) | Rel-12 | 61 | Adrian | WLAN |  |  |  |  |
| 4623 | 1626.2.3.2 | CT1 part of Stage 3 for BB1: Policy and Charging Control for supporting traffic from fixed terminals and NSWO traffic from 3GPP UEs in fixed broadband access networks | 65d? | 2013-12-06 A | 2014-03-05 A | 100% | 2013-12-06 | 2014-03-05 | 65d? | finish no earlier than 2014-03-05 | C1 | 512h | 512h | P4C-F-CT3 | 32 | Huawei | Xia Haitao (xiahaitao@huawei.com) | Rel-12 | 62 | Frederic | WLAN |  |  |  |  |
| 4624 | 1626.2.3.3 | CT4 part of Stage 3 for BB1: Policy and Charging Control for supporting traffic from fixed terminals and NSWO traffic from 3GPP UEs in fixed broadband access networks | 137d? | 2013-12-06 A | 2014-06-13 A | 100% | 2013-12-06 | 2014-06-13 | 137d? | finish no earlier than 2014-06-13 | C4 | 1096h | 1096h | P4C-F-CT3 | 32 | Huawei | Xia Haitao (xiahaitao@huawei.com) | Rel-12 | 62 | Kimmo | WLAN |  |  |  |  |
| 4625 | 1626.2.4 | Policy and Charging Enforcement Function (PCEF) based Charging for traffic from fixed terminals and NSWO traffic from 3GPP UEs in fixed broadband access networks (Stage 2/3) | 326d? | 2013-06-21 A | 2014-09-17 A | 100% | 2013-06-21 | 2014-09-17 | 326d? | finish no earlier than 2014-09-17 | S5 | 2608h | 2608h | P4C-F-CH_P | 31 | Alcatel-Lucent | maryse.gardella@alcatel-lucent.com | Rel-12 | 60 | Mirko | WLAN | P4C-F-CH_P |  |  |  |
| 4626 | 1626.2.5 | Traffic Detection Function (TDF) based Charging for traffic from fixed terminals and NSWO traffic from 3GPP UEs in fixed broadband access networks (Stage 2/3) | 261d? | 2013-06-24 A | 2014-06-18 A | 100% | 2013-06-24 | 2014-06-18 | 261d? | finish no earlier than 2014-06-18 | S5 | 2088h | 2088h | P4C-F-CH_T | 31 | Openet Telecom | alan.mcnamee@openet.com | Rel-12 | 60 | Mirko | WLAN | P4C-F-CH_T |  |  |  |
| 4627 | 1626.3 | **BB2: Policy and Charging Control for 3GPP UEs connected to BroadBand Forum access network as Trusted network in Interworking scenario (P4C-TI)** | 266d? | 2012-06-20 A | 2013-06-19 A | 100% | 2012-06-20 | 2013-06-19 | 266d? |  | S2 | 2610.07h | 2610.07h | P4C-TI | 29 | Alcatel-Lucent | konstantin.livanos@alcatel-lucent.com | Rel-12 | 56 | Maurice |  | P4C-TI |  |  |  |
| 4628 | 1626.3.1 | TR on Stage 2 for BB2: Policy and Charging Control for 3GPP UEs connected to BroadBand Forum access network as Trusted network in Interworking scenario (P4C-TI) | 109.2d? | 2012-06-20 A | 2013-06-19 A | 100% | 2012-06-20 | 2013-06-19 | 109.2d? | finish no earlier than 2013-06-06 | S2 | 862.87h | 862.87h | P4C-TI-SA2TR | 29 | Alcatel-Lucent | konstantin.livanos@alcatel-lucent.com | Rel-12 | 56 | Maurice |  |  |  |  |  |
| 4629 | 1626.3.2 | Stage 2 for BB2: Policy and Charging Control for 3GPP UEs connected to BroadBand Forum access network as Trusted network in Interworking scenario (P4C-TI) | 109.2d? | 2012-06-20 A | 2013-06-19 A | 100% | 2012-06-20 | 2013-06-19 | 109.2d? | finish no earlier than 2013-06-19 | S2 | 873.6h | 873.6h | P4C-TI-SA2 | 29 | Alcatel-Lucent | konstantin.livanos@alcatel-lucent.com | Rel-12 | 56 | Maurice |  |  |  |  |  |
| 4630 | 1626.4 | Deleted - BB3: Policy and Charging Control for 3GPP UEs connected to fixed broadband access network via S2b and S2c reference points for EPC routed traffic (P4C-S2bc) | 128d? | 2012-06-21 A | 2012-12-12 A | 100% | 2012-06-21 | 2012-12-12 | 128d? | finish no earlier than 2012-12-12 | S2 | 1024h | 1024h | P4C-S2bc | 29 | ZTE | Tricci So (tso@zteusa.com) | Rel-12 | 56 | Maurice |  | P4C-S2bc |  | PCG-30 | SP-58 |
| 4631 | 1626.5 | Deleted - BB4: Policy and Charging Control for EPC routed traffic over fixed broadband access networks of 3GPP UEs connected via H(e)NB in convergent scenarios (P4C-HeNB) | 128d? | 2012-06-21 A | 2012-12-12 A | 100% | 2012-06-21 | 2012-12-12 | 128d? | finish no earlier than 2012-12-12 | S2 | 1024h | 1024h | P4C-HeNB | 29 | NEC | Stefan.Schmid@neclab.eu | Rel-12 | 56 | Maurice |  | P4C-HeNB |  | PCG-30 | SP-58 |
| 4632 | 1626.6 | Deleted - BB5: Policy and Charging Control for supporting Layer 2 traffic in fixed broadband access network (P4C-FL2) | 128d? | 2012-06-21 A | 2012-12-12 A | 100% | 2012-06-21 | 2012-12-12 | 128d? | finish no earlier than 2012-12-12 | S2 | 1024h | 1024h | P4C-FL2 | 29 | Huawei | marco.spini@huawei.com | Rel-12 | 56 | Maurice |  | P4C-FL2 |  | PCG-30 | SP-58 |
| 4633 | 1626.7 | Deleted - BB6: Policy and Charging Control for 3GPP UEs connected to fixed broadband access networks via S2a reference point for EPC routed traffic in convergence (P4C-TC) | 129d? | 2012-06-20 A | 2012-12-12 A | 100% | 2012-06-20 | 2012-12-12 | 129d? | finish no earlier than 2012-12-12 | S2 | 1032h | 1032h | P4C-TC | 29 | ZTE | Tricci So (tso@zteusa.com) | Rel-12 | 56 | Maurice |  | P4C-TC |  | PCG-30 | SP-58 |

Notes:
- 4610: Triggered by TR 23.887 Machine Type and other mobile data applications Communications Enhancements (MTCe), TR 37.869 Study on Enhancements MTC and other Mobile Data Applications¦RAN aspects (FS_MTCe_RAN), Rel-11 TR 23.888 SIMTC / Impacted TSs and TRs: UTRA; LTE
- 4611: RP#65 completed / Impacted TSs and TRs: 25.300; 25.304; 25.413; 36.300; 36.304; 36.413; 36.423
- 4612: Triggered by Rel-11 TR 36.888 (FS_LC_MTC_UE) / Impacted TSs and TRs: LTE
- 4613: ¦CD:Thu 18/06/15->Mon 15/06/15¦WID: RP-130848->RP-140522¦Stat Rep: RP-141221->RP-142024 / Impacted TSs and TRs: 36.101; 36.104; 36.133; 36.201; 36.211; 36.212; 36.213; 36.300; 36.302; 36.306; 36.321; 36.331
- 4614: ¦CD:Thu 18/06/15->Mon 15/06/15¦WID: RP-130848->RP-140522¦Stat Rep: RP-141221->RP-142024 1st Apr 15: Compl:65%->90% 1st Apr 15: CD:Sun 15/03/15->Mon 15/06/15 1st Apr 15: Stat Rep: RP-142024->RP-150149 03/07/15: Compl:90%->100% 03/07/15: WID: RP-14052 / Impacted TSs and TRs: 36.101; 36.104; 36.133
- 4615: 03/07/15: Compl:0%->13% 03/07/15: WID: RP-150135->RP-150838 03/07/15: Stat Rep: ->RP-150833 29/09/15: Compl:13%->25% 29/09/15: Stat Rep: RP-150833->RP-151165 ¦1/1/16: Compl:25%->70% ¦1/1/16: CD:Tue 15/12/15->Tue 15/03/16
- 4616: Linked to BBF, IETF work. SP#58 stopped BB3 to BB6. Split BB1 and BB2 into TR and Stage 2 work / Impacted TSs and TRs: Stage 1/2/3
- 4617: SP#57 completed / Impacted TSs and TRs: 22.278
- 4618: -
- 4619: SP#64 TR 23.896 was never sent for approval due to incomplete P4C BBs. SP#61 TR 23.896v100 for Information. Dec.14: 90->100%. Mar15: 23.896 for approval. / Impacted TSs and TRs: new 23.896
- 4620: SP#62 completed / Impacted TSs and TRs: 23.139; 23.203
- 4621: - / Impacted TSs and TRs: Stage 3
- 4622: CP#64 completed / Impacted TSs and TRs: 29.212; 29.213; 29.215; 29.219
- 4623: CP#63 completed / Impacted TSs and TRs: 24.302
- 4624: CP#64 completed / Impacted TSs and TRs: 29.273
- 4625: SP#65 completed. Introduce Charging Characteristics in Convergent scenario, Include missing fixed user location information for NSWO / Impacted TSs and TRs: Stage 2 (32.240; 32.251); Stage 3 (32.298; 32.299)
- 4626: SP#64 completed / Impacted TSs and TRs: Stage 2 (32.240; 32.251); Stage 3 (32.298; 32.299)
- 4627: -
- 4628: SP#60 completed / Impacted TSs and TRs: new 23.839
- 4629: SP#60 completed / Impacted TSs and TRs: 23.139; 23.203
- 4630: SP#58 stopped (at 0% completion) / Impacted TSs and TRs: 23.139; 23.203; new 23.896
- 4631: SP#58 stopped (at 0% completion) / Impacted TSs and TRs: 23.139; 23.203; new 23.896
- 4632: SP#58 stopped (at 0% completion) / Impacted TSs and TRs: 23.139; 23.203; new 23.896
- 4633: SP#58 stopped (at 30% completion) / Impacted TSs and TRs: 23.139; 23.203; new 23.896

| ID | WBS | Task | Duration | Start | Finish | Complete | Baseline start | Baseline finish | Baseline duration | Constraint | Resources | Work | Actual work | Acronym | PCG approved | Impacted TSs and TRs | WI rapporteur name | WI rapporteur e-mail | Release | TSG approved | MCC resp | Acronym_3GU_Export | Status Report | Special Focus Doc | PCG stopped | TSG stopped |
| --- | --- | --- | --- | --- | --- | --- | --- | --- | --- | --- | --- | --- | --- | --- | --- | --- | --- | --- | --- | --- | --- | --- | --- | --- | --- | --- |
| 4634 | 1627 | **IMS Business Trunking for IP-PBX in Static Mode of Operation** | 847.1d? | 2011-09-28 A | 2014-12-09 A | 100% | 2011-09-28 | 2014-09-12 | 782.1d? |  | S2; S1; C1; C3 | 43555.2h | 43555.2h | BusTI | 29 | Stage 1/2/3 | Deutsche Telekom | michele.zarri@telekom.com | Rel-12 | 56 | Maurice | BusTI |  |  |  |  |
| 4635 | 1627.1 | Stage 1 for IMS Business Trunking for IP-PBX in Static Mode of Operation | 64d? | 2011-09-28 A | 2012-09-12 A | 100% | 2011-09-28 | 2012-09-12 | 64d? | finish no earlier than 2012-08-30 | S1 | 504h | 504h | BusTI-SA1 | 29 | 22.228 | Deutsche Telekom | kurt.bischinger@t-mobile.at | Rel-12 | 56 | Alain |  |  |  |  |  |
| 4636 | 1627.2 | TR on IMS Business Trunking for IP-PBX in Static Mode of Operation | 268d? | 2012-06-18 A | 2013-06-19 A | 100% | 2012-06-18 | 2013-06-19 | 268d? | finish no earlier than 2013-06-19 | S2; S1 | 4288h | 4288h | BusTI-SATR | 29 | new 23.897 | Deutsche Telekom | michele.zarri@telekom.com | Rel-12 | 56 | Maurice |  |  |  |  |  |
| 4637 | 1627.3 | Stage 2 for IMS Business Trunking for IP-PBX in Static Mode of Operation | 263d? | 2012-06-25 A | 2013-06-19 A | 100% | 2012-06-25 | 2013-06-19 | 263d? | finish no earlier than 2013-06-19 | S2 | 2104h | 2104h | BusTI-SA2 | 29 | 23.228 | Deutsche Telekom | michele.zarri@telekom.com | Rel-12 | 56 | Maurice |  |  |  |  |  |
| 4638 | 1627.4 | **CT aspects of IMS Business Trunking for IP-PBX in Static Mode of Operation (Stage 3)** | 333d? | 2013-09-06 A | 2014-12-09 A | 100% | 2013-09-06 | 2014-09-12 | 268d? |  | C1; C3 | 9552h | 9552h | BusTI-CT | 31 | Stage 3 | Deutsche Telekom | michael.kreipl@telekom.de | Rel-12 | 61 | Frederic | BusTI-CT |  |  |  |  |
| 4639 | 1627.4.1 | CT1 part of CT aspects of IMS Business Trunking for IP-PBX in Static Mode of Operation (Stage 3) | 329d? | 2013-09-06 A | 2014-12-09 A | 100% | 2013-09-06 | 2014-09-12 | 267d? | finish no earlier than 2014-12-09 | C1 | 2632h | 2632h | BusTI-CT | 31 | 23.218; 24.229; 24.525 (transfer of ETSI 182 025) | Deutsche Telekom | michael.kreipl@telekom.de | Rel-12 | 61 | Frederic |  | CP-140607 |  |  |  |
| 4640 | 1627.4.2 | CT3 part of CT aspects of IMS Business Trunking for IP-PBX in Static Mode of Operation (Stage 3) | 201d? | 2013-09-06 A | 2014-06-11 A | 100% | 2013-09-06 | 2014-06-13 | 201d? | finish no earlier than 2014-06-13 | C3 | 1608h | 1608h | BusTI-CT | 31 | 29.165 | Deutsche Telekom | michael.kreipl@telekom.de | Rel-12 | 61 | Adrian |  |  |  |  |  |
| 4641 | 1628 | **WLAN Network Selection for 3GPP Terminals** | 659d? | 2012-06-18 A | 2014-12-09 A | 100% | 2012-06-18 | 2014-09-12 | 594d? |  | S2; S1; S3; C1 | 35272h | 35272h | WLAN_NS | 29 | Stage 1/2/3 | Intel | vivek.g.gupta@intel.com | Rel-12 | 56 | Maurice | WLAN_NS |  | WLAN |  |  |
| 4642 | 1628.1 | TR on Stage 2 for WLAN Network Selection for 3GPP Terminals | 396d? | 2012-06-18 A | 2013-12-11 A | 100% | 2012-06-18 | 2013-12-11 | 396d? | finish no earlier than 2013-12-11 | S2; S1 | 6336h | 6336h | WLAN_NS-SATR | 29 | New 23.865 | Intel | vivek.g.gupta@intel.com | Rel-12 | 56 | Maurice |  |  | WLAN |  |  |
| 4643 | 1628.2 | Stage 2 for WLAN Network Selection for 3GPP Terminals | 392d? | 2012-06-22 A | 2013-12-11 A | 100% | 2012-06-22 | 2013-12-11 | 392d? | finish no earlier than 2013-12-11 | S2 | 3136h | 3136h | WLAN_NS-SA2 | 29 | 23.402; 23.865 | Intel | vivek.g.gupta@intel.com | Rel-12 | 56 | Maurice |  |  | WLAN |  |  |
| 4644 | 1628.3 | Deleted - TR on Security Aspects of WLAN Network Selection for 3GPP Terminals | 326d? | 2012-12-13 A | 2014-03-07 A | 100% | 2012-12-13 | 2014-03-07 | 326d? | finish no earlier than 2014-03-07 | S3 | 2608h | 2608h | WLAN_Nsdel | 30 | New 33.865 | Huawei | Lydia Xu (xuyixian@huawei.com) | Rel-12 | 58 | Mirko |  |  | WLAN | PCG-32 | CP-63 |
| 4645 | 1628.4 | CT aspects of WLAN Network Selection for 3GPP Terminals (Stage 3) | 263d? | 2013-12-06 A | 2014-12-09 A | 100% | 2013-12-06 | 2014-09-12 | 201d? | finish no earlier than 2014-12-09 | C1 | 2104h | 2104h | WLAN_NS-CT | 32 | 24.302; 24.312 | Qualcomm | Amer Catovic, amerc@qualcomm.com | Rel-12 | 62 | Frederic | WLAN_NS-CT | CP-140622 | WLAN |  |  |
| 4646 | 1629 | **Deleted - IMS Registration Control** | 496d? | 2012-01-31 A | 2013-12-11 A | 100% | 2012-01-31 | 2013-12-11 | 496d? |  | S1; S2; C1; C4 | 23400h | 23400h | IMS_RegCon | 29 | Stage 1/2/3 | China Mobile | lulu@chinamobile.com | Rel-12 | 57 | Alain | IMS_RegCon |  |  | PCG-32 | SP-62 |
| 4647 | 1629.1 | Deleted - Stage 1 for IMS Registration Control | 164d? | 2012-01-31 A | 2012-09-12 A | 100% | 2012-01-31 | 2012-09-12 | 164d? | finish no earlier than 2012-09-12 | S1 | 1304h | 1304h | IMS_RegCon-del1 | 29 | 22.228 | China Mobile | lulu@chinamobile.com | Rel-12 | 57 | Alain |  |  |  | PCG-32 | SP-62 |
| 4648 | 1629.2 | Deleted - Stage 2 for IMS Registration Control | 262d? | 2012-12-13 A | 2013-12-11 A | 100% | 2012-12-13 | 2013-12-11 | 262d? | finish no earlier than 2013-12-11 | S2 | 2096h | 2096h | IMS_RegCon-del2 | 30 | 23.228 | China Mobile | Jiang Yi (jiangyi@chinamobile.com) | Rel-12 | 58 | Maurice |  |  |  | PCG-32 | SP-62 |
| 4649 | 1629.3 | **Deleted - CT aspects of IMS registration control** | 129d? | 2013-06-19 A | 2013-12-11 A | 100% | 2013-06-19 | 2013-12-11 | 129d? |  | C1; C4 | 4128h | 4128h | IMS_RegCon-CT | 31 | Stage 2/3 | China Mobile | Jiang Yi (jiangyi@chinamobile.com) | Rel-12 | 60 | Frederic | IMS_RegCon-CT |  |  | PCG-32 | SP-62 |
| 4650 | 1629.3.1 | Deleted - CT1 aspects of CT aspects of IMS registration control (Stage 2/3) | 129d? | 2013-06-19 A | 2013-12-11 A | 100% | 2013-06-19 | 2013-12-11 | 129d? | finish no earlier than 2013-12-11 | C1 | 1032h | 1032h | IMS_RegCon-CT1 | 31 | 23.218; 24.229 | China Mobile | Jiang Yi (jiangyi@chinamobile.com) | Rel-12 | 60 | Frederic |  |  |  | PCG-32 | SP-62 |
| 4651 | 1629.3.2 | Deleted - CT4 aspects of CT aspects of IMS registration control (Stage 3) | 129d? | 2013-06-19 A | 2013-12-11 A | 100% | 2013-06-19 | 2013-12-11 | 129d? | finish no earlier than 2013-12-11 | C4 | 1032h | 1032h | IMS_RegCon-CT4 | 31 | 29.228; 29.229; 23.008 | China Mobile | Jiang Yi (jiangyi@chinamobile.com) | Rel-12 | 60 | Kimmo |  |  |  | PCG-32 | SP-62 |
| 4652 | 1630 | **Proximity-based Services** | 1186d? | 2012-12-13 A | 2017-06-15 A | 100% | 2012-12-13 | 2015-03-13 | 593d? |  |  | 36376.8h | 36376.8h | ProSe | 30 | Stage 1/2 | Qualcomm | Rich Hovey (rhovey@qualcomm.com) | Rel-12 | 58 | Alain | ProSe |  | Public Safety (A-A) |  |  |
| 4653 | 1630.1 | Stage 1 for Proximity-based Services | 137d? | 2012-12-13 A | 2013-06-19 A | 100% | 2012-12-13 | 2013-06-19 | 137d? | finish no earlier than 2013-06-19 | S1 | 1088h | 1088h | ProSe-SA1 | 30 | 22.115; 22.278 | Qualcomm | Rich Hovey (rhovey@qualcomm.com) | Rel-12 | 58 | Alain |  |  | Public Safety (A-A) |  |  |
| 4654 | 1630.2 | TR on Stage 2 for Proximity-based Services | 327d? | 2012-12-13 A | 2014-03-07 A | 100% | 2012-12-13 | 2014-03-07 | 327d? | finish no earlier than 2014-03-07 | S2 | 2608h | 2608h | ProSe-SA2TR | 30 | New 23.703 | Qualcomm | Haris Zisimopoulos (harisz@qti.qualcomm.com) | Rel-12 | 58 | Maurice |  |  | Public Safety (A-A) |  |  |
| 4655 | 1630.3 | Stage 2 for Proximity-based Services | 397d? | 2012-12-19 A | 2014-06-18 A | 100% | 2012-12-19 | 2014-06-18 | 397d? | finish no earlier than 2014-06-18 | S2 | 3168.8h | 3168.8h | ProSe-SA2 | 30 | New 23.303 | Qualcomm | Haris Zisimopoulos (harisz@qti.qualcomm.com) | Rel-12 | 58 | Maurice |  |  | Public Safety (A-A) |  |  |
| 4656 | 1630.4 | Security for Proximity-based Services | 464d? | 2013-03-13 A | 2014-12-12 A | 100% | 2013-03-13 | 2014-06-18 | 336d? | finish no earlier than 2014-12-12 | S3 | 3712h | 3712h | ProSe-SA3 | 30 | 33.220; New 33.303 | Qualcomm | Adrian Escott (aescott@qti.qualcomm.com) | Rel-12 | 59 | Mirko |  | SP-140584 | Public Safety (A-A) |  |  |
| 4657 | 1630.5 | (IETF) Security for Proximity-based Services (ietf-avtcore-srtp-aes-gcm) | 63d? | 2014-09-12 A | 2014-12-09 A | 100% |  |  |  | finish no earlier than 2014-12-09 | S3-IETF | 504h | 504h | ProSe | 33 | RFC 7714 (was ietf-avtcore-srtp-aes-gcm); RFC 7714 | Atle Monrad | atle.monrad@ericsson.com | Rel-12 | 65 |  |  |  | Public Safety (A-A) |  |  |

Notes:
- 4634: Linked to Rel-11 IPXS Feature UID_470051 Advanced IP Interconnection of Services. This WI defines a generic framework for interconnecting with any type of IMS based network including IP-PBXs.
- 4635: SP#57 completed. 22.228CR#0171
- 4636: SP#60 completed
- 4637: SP#60 completed
- 4638: -
- 4639: CP#65 completion 09/14=>12/14. Exception in CP-140607. Dec.14: 85->100%
- 4640: CP#64 completed
- 4641: Evaluate and if needed enhance existing 3GPP solutions for WLAN network selection taking into account WFA Hotspot 2.0 solutions
- 4642: SP#62 completed
- 4643: SP#62 completed
- 4644: SP#63 stopped (84% complete)
- 4645: CP#65 completion 09/14=>12/14. CP#65 exception CP-140622. Dec.14: 95->100%
- 4646: SP#62 stopped. Specify for fixed line the requirement of controlling user registration to IMS based on network information related to user location (e.g. IP address, DSLAM information)
- 4647: SP#57 completed
- 4648: SP#62 stopped at 50% completion
- 4649: SP#62 no CT/Stage 3 work is needed (stopped at 0% completion)
- 4650: SP#62 no CT/Stage 3 work is needed (stopped at 0% completion)
- 4651: SP#62 no CT/Stage 3 work is needed (stopped at 0% completion)
- 4652: SP#65 SA3 updated the SA-wide WID SP-140300=>SP-140574 (Moved the TR phase to Rel-13 as a stand-alone Study). Triggered by Rel-12 TR 22.803 Study on Proximity-based Services (FS_ProSe) UID_530044
- 4653: SP#60 completed
- 4654: SP#63 completed. TR 23.703v200 for Approval
- 4655: SP#64 completed open issue/alignment to RAN/SA3 decisions. SP#63 TS 23.303v100 for 1-step Approval
- 4656: SP#65 re-opened. Completion 06/14=>12/14. Exception in SP-140584. Updated WID SP-140300=>SP-140574 (Moved the TR phase to Rel-13 as a stand-alone Study). SP#64 completed. TS 33.303 v100 for 1-step Approval¦Aug2015: 90%->100
- 4657: Submitted to IESG for publication¦7/3/16: 75%->100; 9/4/21: RFC 7714 added;

| ID | WBS | Task | Duration | Start | Finish | Complete | Baseline start | Baseline finish | Baseline duration | Constraint | Resources | Work | Actual work | Acronym | PCG approved | WI rapporteur name | WI rapporteur e-mail | Release | TSG approved | Status Report | Special Focus Doc | Acronym_3GU_Export | MCC resp |
| --- | --- | --- | --- | --- | --- | --- | --- | --- | --- | --- | --- | --- | --- | --- | --- | --- | --- | --- | --- | --- | --- | --- | --- |
| 4658 | 1630.6 | **Charging Aspects of Proximity-based Services** | 195d? | 2014-06-19 A | 2015-03-13 A | 100% | 2014-06-18 | 2014-09-17 | 66d? |  | S5 | 4160h | 4160h | ProSe-CH | 33 | Qualcomm | Cheng Hong (hongc@qti.qualcomm.com) | Rel-12 | 64 | SP-140543 | Public Safety (A-A) | ProSe-CH |  |
| 4659 | 1630.6.1 | Study on Charging support for ProSe one-to-many Direct Communication for Public Safety use | 130d? | 2014-06-19 A | 2014-12-12 A | 100% | 2014-06-18 | 2014-09-17 | 66d? | finish no earlier than 2014-12-12 | S5 | 1040h | 1040h | ProSe-CH-SA5TR | 33 | Qualcomm | Cheng Hong (hongc@qti.qualcomm.com) | Rel-12 | 64 | SP-140543 | Public Safety (A-A) |  |  |
| 4660 | 1630.6.2 | Specification of Charging Aspects of Proximity-based Services | 195d? | 2014-06-19 A | 2015-03-13 A | 100% | 2014-06-18 | 2014-09-17 | 66d? | finish no earlier than 2015-03-13 | S5 | 1560h | 1560h | ProSe-CH-SA5 | 33 | Qualcomm | Cheng Hong (hongc@qti.qualcomm.com) | Rel-12 | 64 | SP-140543 | Public Safety (A-A) |  |  |
| 4661 | 1630.7 | **CT aspects of Proximity-based Services (Stage 3)** | 203d? | 2014-03-05 A | 2014-12-09 A | 100% | 2014-03-05 | 2014-09-12 | 138d? |  |  | 6392h | 6392h | ProSe-CT | 32 | Qualcomm | Lena Chaponniere (lguellec@qti.qualcomm.com) | Rel-12 | 63 |  | Public Safety (A-A) | ProSe-CT | Frederic |
| 4662 | 1630.7.1 | CT1 part of CT aspects of Proximity-based Services | 200d? | 2014-03-05 A | 2014-12-09 A | 100% | 2014-03-05 | 2014-09-12 | 138d? | finish no earlier than 2014-12-09 | C1 | 1600h | 1600h | ProSe-CT | 32 | Qualcomm | Lena Chaponniere (lguellec@qti.qualcomm.com) | Rel-12 | 63 | CP-140615 | Public Safety (A-A) |  | Frederic |
| 4663 | 1630.7.2 | CT3 part of CT aspects of Proximity-based Services | 200d? | 2014-03-05 A | 2014-12-09 A | 100% | 2014-03-05 | 2014-09-12 | 138d? | finish no earlier than 2014-12-09 | C3 | 1600h | 1600h | ProSe-CT | 32 | Qualcomm | Lena Chaponniere (lguellec@qti.qualcomm.com) | Rel-12 | 63 | CP-140568 | Public Safety (A-A) |  | Adrian |
| 4664 | 1630.7.3 | CT4 part of CT aspects of Proximity-based Services | 200d? | 2014-03-05 A | 2014-12-09 A | 100% | 2014-03-05 | 2014-09-12 | 138d? | finish no earlier than 2014-12-09 | C4 | 1600h | 1600h | ProSe-CT | 32 | Qualcomm | Lena Chaponniere (lguellec@qti.qualcomm.com) | Rel-12 | 63 | CP-140484 | Public Safety (A-A) |  | Kimmo |
| 4665 | 1630.7.4 | CT6 part of CT aspects of Proximity-based Services | 199d? | 2014-03-06 A | 2014-12-09 A | 100% | 2014-03-06 | 2014-09-12 | 137d? | finish no earlier than 2014-12-09 | C6 | 1592h | 1592h | ProSe-CT | 32 | Qualcomm | Lena Chaponniere (lguellec@qti.qualcomm.com) | Rel-12 | 63 | CP-140695 | Public Safety (A-A) |  | Xavier |
| 4666 | 1630.8 | **LTE Device to Device Proximity Services** | 857d? | 2014-03-11 A | 2017-06-15 A | 100% | 2014-03-06 | 2015-03-13 | 267d? |  |  | 14744h | 14744h | LTE_D2D_Prox | 32 | Qualcomm | Shailesh Patil (patil@qti.qualcomm.com) | Rel-12 | 63 |  | Public Safety (A-A) | LTE_D2D_Prox | Patrick |
| 4667 | 1630.8.1 | Core part: LTE Device to Device Proximity Services | 263d? | 2014-03-15 A | 2015-03-13 A | 100% | 2014-07-11 | 2014-09-12 | 45.67d? | finish no earlier than 2015-03-15 | R1; R2; R4 | 6312h | 6312h | LTE_D2D_Prox-Core | 32 | Qualcomm | Shailesh Patil (patil@qti.qualcomm.com) | Rel-12 | 63 | RP-150094 | Public Safety (A-A) | LTE_D2D_Prox-Core | Patrick |
| 4668 | 1630.8.2 | Perf. part: LTE Device to Device Proximity Services | 464d? | 2014-03-11 A | 2015-12-15 A | 100% | 2014-03-06 | 2015-03-13 | 267d? | finish no earlier than 2015-12-15 | R4 | 3712h | 3712h | LTE_D2D_Prox-Perf | 32 | Qualcomm | Shailesh Patil (patil@qti.qualcomm.com) | Rel-12 | 63 | RP-151276 | Public Safety (A-A) | LTE_D2D_Prox-Perf | Issam |
| 4669 | 1630.8.3 | UE Conformance Test Aspects – LTE Device-to-Device Proximity Services | 590d? | 2015-03-16 A | 2017-06-15 A | 100% |  |  |  | finish no earlier than 2017-06-15 | R5 | 4720h | 4720h | LTE_D2D_Prox-UEConTest | 34 | Qualcomm | svora@qti.qualcomm.com | Rel-12 | 67 |  |  |  |  |
| 4670 | 1631 | **Web Real Time Communication access to IMS** | 1635d? | 2012-12-14 A | 2019-03-07 A | 100% | 2012-12-14 | 2014-12-10 | 525d? |  | S1; S2; S3 | 91745.9h | 91745.9h | IMS_WebRTC | 30 | China Mobile | lulu@chinamobile.com | Rel-12 | 58 |  |  | IMS_WebRTC | Alain |
| 4671 | 1631.1 | Stage 1 for Web Real Time Communication access to IMS | 136d? | 2012-12-14 A | 2013-06-19 A | 100% | 2012-12-14 | 2013-06-19 | 136d? | finish no earlier than 2013-06-19 | S1 | 1088h | 1088h | IMS_WebRTC | 30 | China Mobile | lulu@chinamobile.com | Rel-12 | 58 |  |  |  | Alain |
| 4672 | 1631.2 | TR on Stage 2 for Web Real Time Communication access to IMS | 126d? | 2013-06-19 A | 2013-12-11 A | 100% | 2013-06-19 | 2013-12-11 | 126d? | finish no earlier than 2013-12-11 | S2 | 1008h | 1008h | IMS_WebRTC | 31 | China Mobile | Yu Qing (yuqing@chinamobile.com) | Rel-12 | 60 |  |  |  | Maurice |
| 4673 | 1631.3 | Stage 2 for Web Real Time Communication access to IMS | 192d? | 2013-06-19 A | 2014-03-07 A | 100% | 2013-06-19 | 2014-03-07 | 192d? | finish no earlier than 2014-03-07 | S2 | 1528h | 1528h | IMS_WebRTC | 31 | China Mobile | Yu Qing (yuqing@chinamobile.com) | Rel-12 | 60 |  |  |  | Maurice |
| 4674 | 1631.4 | (IETF) Web Real Time Communication access to IMS (draft-ietf-rtcweb-overview) | 391d? | 2013-06-25 A | 2014-12-12 A | 100% | 2013-06-19 | 2014-12-10 | 389d? | finish no earlier than 2014-12-12 | C1-IETF | 3128h | 3128h | IMS_WebRTC | 32 | Uwe Rauschenbach | Uwe Rauschenbach | Rel-12 | 63 |  |  |  |  |
| 4675 | 1631.5 | (IETF) WebRTC Data Channel Establishment Protocol (draft-ietf-rtcweb-data-protocol) | 391d | 2013-06-25 A | 2014-12-12 A | 100% |  |  |  | finish no earlier than 2014-12-12 | C1-IETF | 3128h | 3128h | IMS_WebRTC | 45 |  |  | Rel-12 | 88 |  |  |  |  |
| 4676 | 1631.6 | TR on Security for Web Real Time Communication access to IMS | 202d? | 2013-12-11 A | 2014-09-17 A | 100% | 2013-12-11 | 2014-09-17 | 202d? | finish no earlier than 2014-09-17 | S3 | 1608h | 1608h | IMS_WebRTC | 32 | Ericsson | oscar.ohlsson@ericsson.com | Rel-12 | 62 |  |  |  | Mirko |
| 4677 | 1631.7 | Security for Web Real Time Communication access to IMS | 202d? | 2013-09-12 A | 2014-06-18 A | 100% | 2013-09-12 | 2014-06-18 | 202d? | finish no earlier than 2014-06-18 | S3 | 1609.85h | 1609.85h | IMS_WebRTC | 31 | Ericsson | oscar.ohlsson@ericsson.com | Rel-12 | 61 |  |  |  | Mirko |
| 4678 | 1631.8 | **CT aspects of Web Real Time Communication (WebRTC) Access to IMS** | 1311d? | 2014-03-05 A | 2019-03-07 A | 100% | 2014-03-05 | 2014-12-05 | 198d? |  | C1; C4; IETF | 39408h | 39408h | IMS_WebRTC-CT | 32 | China Mobile | Jiang Yi (jiangyi@chinamobile.com) | Rel-12 | 63 |  |  | IMS_WebRTC-CT | Frederic |
| 4679 | 1631.8.1 | (IETF) Trickle ICE: Incremental Provisioning of Candidates for the Interactive Connectivity Establishment (ICE) Protocol (draft-ietf-ice-trickle) | 1d | 2019-03-07 A | 2019-03-07 A | 100% |  |  |  |  | C1-IETF | 8h | 8h | IMS_WebRTC-CT | 44 |  |  | Rel-12 | 87 |  |  |  |  |
| 4680 | 1631.8.2 | (IETF) Trickle ICE: Incremental Provisioning of Candidates for the Interactive Connectivity Establishment (ICE) Protocol (draft-ietf-ice-trickle) | 1d | 2019-03-07 A | 2019-03-07 A | 100% |  |  |  |  | C1-IETF | 8h | 8h | IMS_WebRTC-CT | 44 |  |  | Rel-12 | 87 |  |  |  |  |
| 4681 | 1631.8.3 | CT1 part of CT aspects of Web Real Time Communication (WebRTC) Access to IMS | 200d? | 2014-03-05 A | 2014-12-09 A | 100% | 2014-03-05 | 2014-09-12 | 138d? | finish no earlier than 2014-12-09 | C1 | 1600h | 1600h | IMS_WebRTC-CT1 | 32 | China Mobile | Jiang Yi (jiangyi@chinamobile.com) | Rel-12 | 63 | CP-140621 |  |  | Frederic |
| 4682 | 1631.8.4 | (IETF) Web Real Time Communication access to IMS (draft-ietf-rtcweb-data-channel) | 200d? | 2014-03-06 A | 2014-12-09 A | 100% | 2014-03-05 | 2014-12-05 | 198d? | finish no earlier than 2014-12-09 | C1-IETF | 1600h | 1600h | IMS_WebRTC-data | 33 | christer.holmberg@ericsson.com | christer.holmberg@ericsson.com | Rel-12 | 64 |  |  |  |  |
| 4683 | 1631.8.5 | (IETF) Web Real Time Communication access to IMS (draft-ietf-rtcweb-stun-consent-freshness) | 200d? | 2014-03-06 A | 2014-12-09 A | 100% | 2014-03-05 | 2014-12-05 | 198d? | finish no earlier than 2014-12-09 | C1-IETF | 1600h | 1600h | IMS_WebRTC-stun | 33 | christer.holmberg@ericsson.com | christer.holmberg@ericsson.com | Rel-12 | 64 |  |  |  |  |
| 4684 | 1631.8.6 | Deleted - (IETF) Web Real Time Communication access to IMS (draft-ietf-sipcore-sip-authn) | 63d? | 2014-09-12 A | 2014-12-05 A | 100% |  |  |  | finish no earlier than 2014-12-09 | C1-IETF | 504h | 504h | IMS_WebRTC-yusef | 33 | christer.holmberg@ericsson.com | christer.holmberg@ericsson.com | Rel-12 | 65 |  |  |  |  |
| 4685 | 1631.8.7 | (IETF) Third-Party Token-based Authentication and Authorization for Session Initiation Protocol (SIP) (draft-ietf-sipcore-sip-token-authnz) | 63d? | 2014-09-12 A | 2014-12-05 A | 100% |  |  |  | finish no earlier than 2014-12-09 | C1-IETF | 504h | 504h | IMS_WebRTC-yusef | 44 |  |  | Rel-12 | 87 |  |  |  |  |
| 4686 | 1631.8.8 | Deleted - (IETF) Web Real Time Communication access to IMS (draft-holmberg-sipcore-auth-id) | 65d? | 2014-09-12 A | 2014-12-09 A | 100% |  |  |  | start no earlier than 2014-09-12 | C1-IETF | 520h | 520h | IMS_WebRTC-holmb | 34 | christer.holmberg@ericsson.com |  | Rel-12 | 66 |  |  |  |  |
| 4687 | 1631.8.9 | CT4 part of CT aspects of Web Real Time Communication (WebRTC) Access to IMS | 200d? | 2014-03-05 A | 2014-12-09 A | 100% | 2014-03-05 | 2014-09-19 | 143d? | finish no earlier than 2014-12-09 | C4 | 1600h | 1600h | IMS_WebRTC-CT4 | 32 | China Mobile | Jiang Yi (jiangyi@chinamobile.com) | Rel-12 | 63 | CP-140732 |  |  | Kimmo |

Notes:
- 4658: SP#65 exception in SP-140543. Mar15: 85->100% / Impacted TSs and TRs: Stage 2/3
- 4659: SP#65 completion 09/14=>12/14. Exception in SP-140543. TR 32.844v100 for Information. Dec.14: CD: 09/14->12/14, 60->100% / Impacted TSs and TRs: New 32.844
- 4660: SP#65 completion 09/14=>12/14. Exception in SP-140543. SP#65 TR 32.277v100 for Information. Dec.14: CD: 09/14->03/15, 40->75%. Mar15: 75->100% / Impacted TSs and TRs: 32.240; 32.297; 32.298; 32.299; New 32.277
- 4661: CP#64 updated WID CP-140194=>CP-140290 / Impacted TSs and TRs: Stage 3
- 4662: CP#65 completion 09/14=>12/14. Exception in CP-140615. TS 24.333/4v200 for Approval. Dec.14: 90->100% / Impacted TSs and TRs: 24.301; 23.122; New TSs (24.333; 24.334)
- 4663: CP#65 completion 09/14=>12/14. TS 29.343v100 for 1-step Approval. Exception in CP-140568. Dec.14: 90->100 / Impacted TSs and TRs: New 29.343
- 4664: CP#65 completion 09/14=>12/14. TS 29.344/5v100 for 1-step Approval. Exception in CP-140484. Dec.14: 90->100 / Impacted TSs and TRs: 29.272; 23.008; 23.003; New TSs (29.344; 29.345)
- 4665: CP#65 completion 09/14=>12/14. Exception in CP-140695. Dec.14: 60->100% / Impacted TSs and TRs: 31.102
- 4666: follow-up of TR 36.843 FS_LTE_D2D_Prox / Impacted TSs and TRs: LTE
- 4667: ¦CD:Sat 15/03/14->Sun 15/03/15Compl:0%->95%¦CD:Fri 13/03/15->Sun 15/03/15¦Stat Rep: RP-141244->RP-141894 1st Apr 15: Compl:95%->100% 1st Apr 15: Stat Rep: RP-141894->RP-150094 / Impacted TSs and TRs: 36.101; 36.133; 36.211; 36.212; 36.213; 36.214; 36.300; 36.304; 36.306; 36.321; 36.322; 36.323; 36.331; 36.413; 36.423; New 36.877
- 4668: ¦CD:Sat 15/03/14->Sun 15/03/15¦Stat Rep: RP-141244->RP-141894 1st Apr 15: Compl:10%->25% 1st Apr 15: Stat Rep: RP-141894->RP-150094 03/07/15: Compl:25%->70% 03/07/15: Stat Rep: RP-150094->RP-150760 29/09/15: Compl:70%->95% 29/09/15: CD:Tue 15/09/15-> / Impacted TSs and TRs: 36.101; 36.133
- 4669: rapporteur e-mail added 03/07/15: Compl:0%->10% 03/07/15: Stat Rep: ->RP-150765 29/09/15: Compl:10%->30% 29/09/15: CD:Tue 15/12/15->Wed 15/06/16 29/09/15: Stat Rep: RP-150765->RP-151280 1/1/16: Compl:30%->45% 1/1/16: WID: RP-1¦ ;
- 4670: IETF RTCWEB and W3C WEBRTC groups are specifying a browser-based client to support communication services. Interoperability for WebRTC clients to access 3GPP IMS is needed. / Impacted TSs and TRs: Stage 1/2
- 4671: SP#60 completed / Impacted TSs and TRs: 22.101; 22.228
- 4672: SP#62 completed. TR 23.701v100 for Information & Approval / Impacted TSs and TRs: New 23.701
- 4673: SP#63 completed / Impacted TSs and TRs: 23.228
- 4674: In WGLC. Mar15: responsible WG changed from S2-IETF; 23/4/20: 50%->90; 9/4/21: RFC 8825 added; / Impacted TSs and TRs: draft-ietf-rtcweb-overview; RFC 8825
- 4675: 9/4/21: RFC 8832 added; / Impacted TSs and TRs: RFC 8832
- 4676: SP#65 completed. TR 33.871v200 for Approval / Impacted TSs and TRs: New 33.871
- 4677: SP#64 completed / Impacted TSs and TRs: 33.203; 33.328
- 4678: - / Impacted TSs and TRs: Stage 3
- 4679: 9/4/21: RFC 8838 added; / Impacted TSs and TRs: RFC 8838
- 4680: 9/4/21: RFC 8838 added; / Impacted TSs and TRs: RFC 8838
- 4681: CP#65 TS 24.371v100 for Information. Completion 09/14=>12/14. Exception in CP-140621. Dec.14: 70->90%. 3/3/15: 100% cpltd. / Impacted TSs and TRs: 24.229; New 24.371
- 4682: Submitted to IESG for publication. Mar15: In RFC-Editors queue; 9/4/21: RFC 8831 added; / Impacted TSs and TRs: draft-ietf-rtcweb-data-channel; RFC 8831
- 4683: Mar15: Publication requested¦7/3/16: 50%->100; 9/4/21: RFC 7675 added; / Impacted TSs and TRs: draft-ietf-rtcweb-stun-consent-freshness; RFC 7675
- 4684: work in progress; 23/4/20: 25%->100 / Impacted TSs and TRs: draft-yusef-sipcore-sip-oaut; Replaced by replaced by draft-ietf-sipcore-sip-token-authnz
- 4685: 9/4/21: RFC 8898 added; / Impacted TSs and TRs: RFC 8898
- 4686: 7/3/16: 25%->100 since deleted (draft no longer needed). / Impacted TSs and TRs: draft-holmberg-sipcore-auth-id
- 4687: CP#65 completion 09/14=>12/14. Exception in CP-140732. Dec.14: 30->80%. Mar. 15: 100% / Impacted TSs and TRs: 23.334; 29.334

| ID | WBS | Task | Duration | Start | Finish | Complete | Baseline start | Baseline finish | Baseline duration | Constraint | Resources | Work | Actual work | Acronym | PCG approved | WI rapporteur name | WI rapporteur e-mail | Release | TSG approved | MCC resp | Acronym_3GU_Export | Special Focus Doc | Status Report |
| --- | --- | --- | --- | --- | --- | --- | --- | --- | --- | --- | --- | --- | --- | --- | --- | --- | --- | --- | --- | --- | --- | --- | --- |
| 4688 | 1632 | **Usage Monitoring Control PCC enhancement** | 196d? | 2012-12-13 A | 2013-09-06 A | 100% | 2012-12-13 | 2013-09-06 | 196d? |  | S2; C3 | 4112h | 4112h | UMONC | 30 | ZTE | bi.yifeng@zte.com.cn | Rel-12 | 58 | Maurice | UMONC |  |  |
| 4689 | 1632.1 | Stage 2 for Usage Monitoring Control PCC enhancement | 61d? | 2012-12-13 A | 2013-03-06 A | 100% | 2012-12-13 | 2013-03-06 | 61d? | finish no earlier than 2013-03-06 | S2 | 488h | 488h | UMONC | 30 | ZTE | bi.yifeng@zte.com.cn | Rel-12 | 58 | Maurice |  |  |  |
| 4690 | 1632.2 | CT3 aspects of Usage Monitoring Control PCC enhancement (Stage 3) | 63d? | 2013-06-14 A | 2013-09-06 A | 100% | 2013-06-14 | 2013-09-06 | 63d? | finish no earlier than 2013-09-06 | C3 | 488h | 488h | UMONC-CT3 | 31 | ZTE | zhou.xiaoyun@zte.com.cn | Rel-12 | 60 | Adrian | UMONC-CT3 |  |  |
| 4691 | 1633 | **Application Based Charging** | 340d? | 2013-03-07 A | 2014-06-18 A | 100% | 2013-03-07 | 2014-06-18 | 340d? |  | S2; S5; C3 | 11612h | 11612h | ABC | 30 | Allot | Alla Goldner (agoldner@allot.com) | Rel-12 | 59 | Maurice | ABC |  |  |
| 4692 | 1633.1 | Stage 2 for Application Based Charging | 76d? | 2013-03-07 A | 2013-06-19 A | 100% | 2013-03-07 | 2013-06-19 | 76d? | finish no earlier than 2013-12-11 | S2 | 608h | 608h | ABC-SA2 | 30 | Allot | Alla Goldner (agoldner@allot.com) | Rel-12 | 59 | Maurice |  |  |  |
| 4693 | 1633.2 | Charging for Application Based Charging | 232.5d? | 2013-06-19 A | 2014-06-18 A | 100% | 2013-06-19 | 2014-06-18 | 232.5d? | finish no earlier than 2014-06-18 | S5 | 1836h | 1836h | ABC-CT5 | 31 | Openet Telecom | alan.mcnamee@openet.com | Rel-12 | 60 | Mirko |  |  |  |
| 4694 | 1633.3 | CT3 aspects of Application Based Charging (Stage 3) | 127d? | 2013-06-14 A | 2013-12-06 A | 100% | 2013-06-14 | 2013-12-06 | 127d? | finish no earlier than 2013-12-06 | C3 | 1008h | 1008h | ABC-CT3 | 31 | Allot | Alla Goldner (agoldner@allot.com) | Rel-12 | 60 | Adrian | ABC-CT3 |  |  |
| 4695 | 1634 | **Enhanced S2a Mobility Over trusted WLAN access to EPC** | 332d? | 2013-09-09 A | 2014-12-09 A | 100% | 2013-09-09 | 2014-09-12 | 267d? |  | S2; C1; C4 | 19024h | 19024h | eSaMOG | 31 | ZTE | Tricci So (tso@zteusa.com) | Rel-12 | 61 | Maurice | eSaMOG | WLAN |  |
| 4696 | 1634.1 | Stage 2 for Enhanced S2a Mobility Over trusted WLAN access to EPC | 130d? | 2013-09-11 A | 2014-03-07 A | 100% | 2013-09-11 | 2014-03-07 | 130d? | finish no earlier than 2014-03-07 | S2 | 1032h | 1032h | eSaMOG-SA2 | 31 | ZTE | Tricci So (tso@zteusa.com) | Rel-12 | 61 | Maurice |  | WLAN |  |
| 4697 | 1634.2 | **Stage 3 for Enhanced S2a Mobility Over trusted WLAN access to EPC** | 332d? | 2013-09-09 A | 2014-12-09 A | 100% | 2013-09-09 | 2014-09-12 | 267d? |  | C1; C4 | 10048h | 10048h | eSaMOG-St3 | 31 | ZTE | Joy Zhou (zhou.xingyue@zte.com.cn) | Rel-12 | 61 | Frederic | eSaMOG-St3 | WLAN |  |
| 4698 | 1634.2.1 | CT1 part of Stage 3 for Enhanced S2a Mobility Over trusted WLAN access to EPC | 329d? | 2013-09-09 A | 2014-12-09 A | 100% | 2013-09-09 | 2014-09-12 | 267d? | finish no earlier than 2014-12-09 | C1 | 2624h | 2624h | eSaMOG-St3 | 31 | ZTE | Joy Zhou (zhou.xingyue@zte.com.cn) | Rel-12 | 61 | Frederic |  | WLAN | CP-140608 |
| 4699 | 1634.2.2 | CT4 part of Stage 3 for Enhanced S2a Mobility Over trusted WLAN access to EPC | 266d? | 2013-09-09 A | 2014-09-11 A | 100% | 2013-09-09 | 2014-09-12 | 266d? | finish no earlier than 2014-09-12 | C4 | 2128h | 2128h | eSaMOG-St3 | 31 | ZTE | Joy Zhou (zhou.xingyue@zte.com.cn) | Rel-12 | 61 | Kimmo |  | WLAN |  |
| 4700 | 1635 | **Optimized Offloading to WLAN in 3GPP-RAT Mobility** | 199d? | 2013-09-12 A | 2014-06-13 A | 100% | 2013-09-12 | 2014-06-13 | 199d? |  | S2; C1 | 4800h | 4800h | WORM | 31 | BlackBerry | Steve Barrett (sbarrett@blackberry.com) | Rel-12 | 61 | Maurice | WORM | WLAN |  |
| 4701 | 1635.1 | Stage 2 for Optimized Offloading to WLAN in 3GPP-RAT Mobility | 66d? | 2013-09-12 A | 2013-12-11 A | 100% | 2013-09-12 | 2013-12-11 | 66d? | finish no earlier than 2013-12-11 | S2 | 528h | 528h | WORM-SA2 | 31 | BlackBerry | Steve Barrett (sbarrett@blackberry.com) | Rel-12 | 61 | Maurice |  | WLAN |  |
| 4702 | 1635.2 | CT aspects of Optimized Offloading to WLAN in 3GPP-RAT Mobility (Stage 3) | 136d? | 2013-12-06 A | 2014-06-13 A | 100% | 2013-12-06 | 2014-06-13 | 136d? | finish no earlier than 2014-06-13 | C1 | 1088h | 1088h | WORM-CT | 32 | Intel | Chen-ho Chin (chen-hox.chin@intel.com) | Rel-12 | 62 | Frederic | WORM-CT | WLAN |  |
| 4703 | 1636 | **Network-provided Location information for IMS Trusted WLAN Access Network (TWAN) case** | 264d? | 2013-09-12 A | 2014-09-11 A | 100% | 2013-09-12 | 2014-09-12 | 264d? |  | S2; C3; C1; C4 | 18624h | 18624h | NETLOC_TWAN | 31 | Alcatel-Lucent | Laurent.thiebaut@alcatel-lucent.com | Rel-12 | 61 | Maurice | NETLOC_TWAN | WLAN |  |
| 4704 | 1636.1 | Stage 2 for Network-provided Location information for IMS Trusted WLAN Access Network (TWAN) case | 129d? | 2013-09-12 A | 2014-03-07 A | 100% | 2013-09-12 | 2014-03-07 | 129d? | finish no earlier than 2014-03-07 | S2 | 1024h | 1024h | NETLOC_TWAN-SA2 | 31 | Alcatel-Lucent | Laurent.thiebaut@alcatel-lucent.com | Rel-12 | 61 | Maurice |  |  |  |
| 4705 | 1636.2 | **CT aspects of Network-provided Location information for IMS Trusted WLAN Access Network (TWAN) case (Stage 3)** | 202d? | 2013-12-06 A | 2014-09-11 A | 100% | 2013-12-06 | 2014-09-12 | 202d? |  | C3; C1; C4 | 9152h | 9152h | NETLOC_TWAN-CT | 32 | China Telecom | Xia Xu (xiaxu@ctbri.com.cn) | Rel-12 | 62 | Adrian | NETLOC_TWAN-CT |  |  |
| 4706 | 1636.2.1 | CT3 part of Network-provided Location information for IMS Trusted WLAN Access Network (TWAN) case | 137d? | 2013-12-06 A | 2014-06-13 A | 100% | 2013-12-06 | 2014-06-13 | 137d? | finish no earlier than 2014-06-13 | C3 | 1088h | 1088h | NETLOC_TWAN-CT | 32 | China Telecom | Xia Xu (xiaxu@ctbri.com.cn) | Rel-12 | 62 | Adrian |  |  |  |
| 4707 | 1636.2.2 | CT1 part of Network-provided Location information for IMS Trusted WLAN Access Network (TWAN) case | 201d? | 2013-12-09 A | 2014-09-11 A | 100% | 2013-12-09 | 2014-09-12 | 201d? | finish no earlier than 2014-09-12 | C1 | 1608h | 1608h | NETLOC_TWAN-CT | 32 | China Telecom | Xia Xu (xiaxu@ctbri.com.cn) | Rel-12 | 62 | Frederic |  |  |  |
| 4708 | 1636.2.3 | CT4 part of Network-provided Location information for IMS Trusted WLAN Access Network (TWAN) case | 201d? | 2013-12-06 A | 2014-09-11 A | 100% | 2013-12-06 | 2014-09-12 | 201d? | finish no earlier than 2014-09-12 | C4 | 1608h | 1608h | NETLOC_TWAN-CT | 32 | China Telecom | Xia Xu (xiaxu@ctbri.com.cn) | Rel-12 | 62 | Kimmo |  |  |  |
| 4709 | 1637 | **Core Network Overload - User Location Information reporting improvement** | 203d? | 2013-12-11 A | 2014-09-17 A | 100% | 2013-12-11 | 2014-09-12 | 199d? |  | S2; C3; C4; S5 | 10920h | 10920h | CNO_ULI | 32 | Alcatel-Lucent | nicolas.drevon@alcatel-lucent.com | Rel-12 | 62 | Maurice | CNO_ULI |  |  |
| 4710 | 1637.1 | Stage 2 for Core Network Overload - User Location Information reporting improvement | 64d? | 2013-12-11 A | 2014-03-07 A | 100% | 2013-12-11 | 2014-03-07 | 64d? | finish no earlier than 2014-03-07 | S2 | 504h | 504h | CNO_ULI-SA2 | 32 | Alcatel-Lucent | nicolas.drevon@alcatel-lucent.com | Rel-12 | 62 | Maurice |  |  |  |
| 4711 | 1637.2 | Charging aspects of Core Network Overload – User Location Information reporting improvements | 3d? | 2014-09-15 A | 2014-09-17 A | 100% |  |  |  | finish no earlier than 2014-09-17 | S5 | 24h | 24h | CNO_ULI-CH | 33 | Alcatel-Lucent | maryse.gardella@alcatel-lucent.com | Rel-12 | 65 |  | CNO_ULI-CH |  |  |

Notes:
- 4688: SP#59 Stage 2 completed. Triggered by Rel-12 TR 23.858 Study on Usage Monitoring Control enhancement (UID_520035) / Impacted TSs and TRs: Stage 2/3
- 4689: SP#59 completed. 23.203 CR#0782 (Time Based Usage Monitoring), CR#0784 (Usage Monitoring via Online Charging System) / Impacted TSs and TRs: 23.203
- 4690: CP#61 completed. 2/4/15: acronym changed to "UMONC-CT3" / Impacted TSs and TRs: 29.212; 29.214; 29.215
- 4691: Triggered by TR 23.800 Study on Application Based Charging (FS_ABC) UID_560038 / Impacted TSs and TRs: Stage 2/3
- 4692: SP#60 completed / Impacted TSs and TRs: 23.203
- 4693: SP#64 completed / Impacted TSs and TRs: 32.240; 32.251; 32.296; 32.298; 32.299
- 4694: CP#62 completed / Impacted TSs and TRs: 29.212; 29.213; 29.214; 29.215; 29.219
- 4695: - / Impacted TSs and TRs: Stage 2/3
- 4696: SP#63 completed / Impacted TSs and TRs: 23.402
- 4697: CP#62 updated WID CP-130580=>CP-130715 / Impacted TSs and TRs: Stage 3
- 4698: CP#65 completion 09/14=>12/14. Exception in CP-140608. TS 24.244 v200 for Approval. Dec.14: 95->100% / Impacted TSs and TRs: 24.302; New 24.244 (WLAN control plane protocol for trusted WLAN access to EPC)
- 4699: CP#65 completed / Impacted TSs and TRs: 29.273; 29.274; 29.275
- 4700: Linked to TR 23.890 Study on Optimized Offloading to WLAN in 3GPP-RAT mobility (FS_WORM), SAE for support for non-3GPP accesses, Multi-Access PDN Connectivity (MAPCON), IP Flow Mobility and Seamless WLAN Offload (IFOM), CS Fallback in EPS (SAES-CSFB) / Impacted TSs and TRs: Stage 2/3
- 4701: SP#62 completed / Impacted TSs and TRs: 23.272; 23.401; 23.402
- 4702: CP#64 completed. Stage 3 enabling differentiation/prioritization of 3GPP RATs relative to WLAN for traffic flow routing based on Inter-System Routing Policies / Impacted TSs and TRs: 24.302; 24.312
- 4703: Rel-11 Network Provided Location Information for IMS (NWK-PL2IMS) covers the case where UE is served by a 3GPP RAN. This WI covers the case where the UE is served by a TWAN / Impacted TSs and TRs: Stage 2/3
- 4704: SP#63 completed / Impacted TSs and TRs: 23.203; 23.228; 23.402
- 4705: - / Impacted TSs and TRs: Stage 3
- 4706: CP#64 completed / Impacted TSs and TRs: 29.212; 29.214
- 4707: CP#65 completed / Impacted TSs and TRs: 24.229
- 4708: CP#65 completed / Impacted TSs and TRs: 29.273; 29.274; 29.275; 29.328; 29.329
- 4709: - / Impacted TSs and TRs: Stage 2/3
- 4710: SP#63 completed / Impacted TSs and TRs: 23.060; 23.203; 23.401
- 4711: SP#65 New WID approved & completed. Introduction of Presence Reporting Areas for Charging / Impacted TSs and TRs: 32.251; 32.298; 32.299

| ID | WBS | Task | Duration | Start | Finish | Complete | Baseline start | Baseline finish | Baseline duration | Constraint | Resources | Work | Actual work | Acronym | PCG approved | Impacted TSs and TRs | WI rapporteur name | Release | TSG approved | MCC resp | Acronym_3GU_Export | Special Focus Doc | PCG stopped | TSG stopped | Status Report |
| --- | --- | --- | --- | --- | --- | --- | --- | --- | --- | --- | --- | --- | --- | --- | --- | --- | --- | --- | --- | --- | --- | --- | --- | --- | --- |
| 4712 | 1637.3 | **CT aspects of Core Network Overload – User Location Information reporting improvements** | 138d? | 2014-03-05 A | 2014-09-11 A | 100% | 2014-03-05 | 2014-09-12 | 138d? |  | C3; C4 | 3896h | 3896h | CNO_ULI-CT | 32 | Stage 3 | Alcatel-Lucent | Rel-12 | 63 | Adrian | CNO_ULI-CT |  |  |  |  |
| 4713 | 1637.3.1 | CT3 part of CT aspects of Core Network Overload – User Location Information reporting improvements | 73d? | 2014-03-05 A | 2014-06-13 A | 100% | 2014-03-05 | 2014-06-13 | 73d? | finish no earlier than 2014-06-13 | C3 | 584h | 584h | CNO_ULI-CT | 32 | 29.212; 29.213 | Alcatel-Lucent | Rel-12 | 63 | Adrian |  |  |  |  |  |
| 4714 | 1637.3.2 | CT4 part of CT aspects of Core Network Overload – User Location Information reporting improvements | 138d? | 2014-03-05 A | 2014-09-11 A | 100% | 2014-03-05 | 2014-09-12 | 138d? | finish no earlier than 2014-09-12 | C4 | 1104h | 1104h | CNO_ULI-CT | 32 | 23.008; 29.060; 29.274 | Alcatel-Lucent | Rel-12 | 63 | Kimmo |  |  |  |  |  |
| 4715 | 1638 | Rel-12 Security small Enhancements | 923d? | 2011-03-23 A | 2014-09-17 A | 100% | 2011-03-23 | 2014-06-18 | 859d? | finish no earlier than 2014-09-17 | S3 | 7384h | 7384h | SEC12 | 29 | Stage 2/3 |  | Rel-12 | 56 | Mirko | SEC12 |  |  |  |  |
| 4716 | 1639 | **Security aspects of Public Warning System** | 925d? | 2011-03-23 A | 2014-09-17 A | 100% | 2011-03-23 | 2014-09-17 | 924d? |  | S3; S1 | 36832h | 36832h | PWS_Sec | 26 |  | ST-Ericsson | Rel-12 | 51 | Mirko | PWS_Sec | Public Safety (I-A) |  |  |  |
| 4717 | 1639.1 | Stage 1 for Protection against false PWS Warning Notifications | 65d? | 2012-06-15 A | 2012-09-12 A | 100% | 2012-06-15 | 2012-09-12 | 65d? | finish no earlier than 2012-09-12 | S1 | 512h | 512h | PWS_Sec-SA1 | 29 | 22.268 | Vodafone | Rel-12 | 56 | Alain |  | Public Safety (I-A) |  |  |  |
| 4718 | 1639.2 | TR on SA3 part for Security aspects of Public Warning System | 921d? | 2011-03-23 A | 2014-09-17 A | 100% | 2011-03-23 | 2014-09-17 | 921d? | finish no earlier than 2014-09-17 | S3 | 7360h | 7360h | PWS_Sec-SA3TR | 26 | New 33.869 changed to 33.969 | ST-Ericsson | Rel-12 | 51 | Mirko |  | Public Safety (I-A) |  |  |  |
| 4719 | 1639.3 | Deleted - SA3 part for Security aspects of Public Warning System | 852d? | 2011-03-30 A | 2014-06-18 A | 100% | 2011-03-30 | 2014-06-18 | 852d? | finish no earlier than 2014-06-18 | S3 | 6808h | 6808h | PWS_Sec-del1 | 26 | New 33.269 | ST-Ericsson | Rel-12 | 51 | Mirko |  | Public Safety (I-A) | PCG-33 | SP-64 |  |
| 4720 | 1639.4 | Deleted - Stage 1 for Security aspects of Public Warning System | 330d? | 2011-03-23 A | 2012-06-20 A | 100% | 2011-03-23 | 2012-06-20 | 330d? | start no earlier than 2011-03-23 | S1 | 2640h | 2640h | PWS_Sec-del2 | 26 | 22.268 | ST-Ericsson | Rel-12 | 51 | Alain |  | Public Safety (I-A) | PCG-29 | SP-56 |  |
| 4721 | 1639.5 | Deleted - Stage 2 for Security aspects of Public Warning System | 133d? | 2011-03-23 A | 2011-09-21 A | 100% | 2011-03-23 | 2011-09-21 | 133d? | start no earlier than 2011-03-23 | S2 | 1064h | 1064h | PWS_Sec-del3 | 26 | 23.401 | ST-Ericsson | Rel-12 | 51 | Maurice |  | Public Safety (I-A) | PCG-27 | SP-53 |  |
| 4722 | 1639.6 | Deleted - CT1 part for Security aspects of Public Warning System | 328d? | 2011-03-25 A | 2012-06-20 A | 100% | 2011-03-25 | 2012-06-20 | 328d? | finish no earlier than 2012-06-20 | C1 | 2624h | 2624h | PWS_Sec-del4 | 26 | 23.041 | ST-Ericsson | Rel-12 | 51 | Frederic |  | Public Safety (I-A) | PCG-29 | SP-56 |  |
| 4723 | 1639.7 | Deleted - RAN2 part for Security aspects of Public Warning System | 128d? | 2011-03-25 A | 2011-09-16 A | 100% | 2011-03-25 | 2011-09-16 | 128d? | start no earlier than 2011-03-25 | R2 | 1024h | 1024h | PWS_Sec-del5 | 26 | 36.331 | ST-Ericsson | Rel-12 | 51 | Yong-Jun |  | Public Safety (I-A) | PCG-27 | RP-53 |  |
| 4724 | 1640 | Security enhancements for usage of Generic Bootstrapping Architecture (GBA) from the browser (Stage 2) | 536d? | 2011-06-08 A | 2013-06-19 A | 100% | 2011-06-08 | 2013-06-19 | 536d? | finish no earlier than 2013-06-19 | S3 | 4256h | 4256h | Web_GBA | 27 | 33.220; 33.222; New 33.823 | Nokia | Rel-12 | 52 | Mirko | Web_GBA |  |  |  |  |
| 4725 | 1641 | **Extended IMS media plane security features** | 657d? | 2012-06-20 A | 2014-12-09 A | 100% | 2012-06-20 | 2014-12-10 | 655d? |  | S3; C4; C1; C3; IETF | 73585.2h | 73585.2h | eMEDIASEC | 29 | Stage 2/3 | Vodafone | Rel-12 | 56 | Mirko | eMEDIASEC |  |  |  |  |
| 4726 | 1641.1 | SA3 part of Extended IMS media plane security features (Stage 2) | 530d? | 2012-06-20 A | 2014-06-18 A | 100% | 2012-06-20 | 2014-06-18 | 530d? | finish no earlier than 2014-06-18 | S3 | 4185.2h | 4185.2h | eMEDIASEC-SA3 | 29 | 33.328 | Vodafone | Rel-12 | 56 | Mirko |  |  |  |  |  |
| 4727 | 1641.2 | (IETF) SA3 part of Extended IMS media plane security features (RFC 7345) | 591d? | 2012-06-20 A | 2014-09-12 A | 100% | 2012-06-20 | 2014-12-10 | 654d? | finish no earlier than 2014-09-12 | S3-IETF | 4728h | 4728h | eMEDIASECSA3IETF | 31 | RFC 7345 (was draft-ietf-mmusic-udptl-dtls) | christer.holmberg@ericsson.com | Rel-12 | 61 |  |  |  |  |  |  |
| 4728 | 1641.3 | **CT aspects of Extended IMS media plane security features (Stage 2/3)** | 528d? | 2012-12-13 A | 2014-12-09 A | 100% | 2012-12-13 | 2014-12-05 | 523d? |  | C4; C1; C3; IETF | 38392h | 38392h | eMEDIASEC-CT | 30 | Stage 2/3 | Alcatel-Lucent | Rel-12 | 58 | Kimmo | eMEDIASEC-CT |  |  |  |  |
| 4729 | 1641.3.1 | TR on Extended IMS media plane security features and TCP related NAT traversal support; IMS H.248 profiles aspects | 461d? | 2012-12-13 A | 2014-09-11 A | 100% | 2012-12-13 | 2014-09-12 | 461d? | finish no earlier than 2014-09-12 | C4 | 3688h | 3688h | eMEDIASEC-CT | 30 | New 29.828 | Alcatel-Lucent | Rel-12 | 58 | Kimmo |  |  |  |  |  |
| 4730 | 1641.3.2 | CT4 part of CT aspects of Extended IMS media plane security features | 520d? | 2012-12-19 A | 2014-12-09 A | 100% | 2012-12-19 | 2014-09-12 | 458d? | finish no earlier than 2014-12-09 | C4 | 4160h | 4160h | eMEDIASEC-CT | 30 | 23.334; 29.334; 29.238; 23.333; 29.333 | Alcatel-Lucent | Rel-12 | 58 | Kimmo |  |  |  |  | CP-140479 |
| 4731 | 1641.3.3 | (IETF) CT4 part of Extended IMS media plane security features (RFC 7345) | 457d? | 2012-12-18 A | 2014-09-11 A | 100% | 2012-12-18 | 2014-12-05 | 519d? | finish no earlier than 2014-09-11 | C4-IETF | 3656h | 3656h | eMEDIASEC-CT | 32 | RFC 7345 (was draft-ietf-mmusic-udptl-dtls) | christer.holmberg@ericsson.com | Rel-12 | 62 |  |  |  |  |  |  |
| 4732 | 1641.3.4 | (IETF) CT4 part of Extended IMS media plane security features (draft-schwarz-mmusic-sdp-for-gw) | 129d? | 2014-06-12 A | 2014-12-09 A | 100% | 2014-06-12 | 2014-12-05 | 127d? | finish no earlier than 2014-12-09 | C4-IETF | 1032h | 1032h | eMEDIASEC-CT | 33 | draft-schwarz-mmusic-sdp-for-gw | christer.holmberg@ericsson.com | Rel-12 | 64 |  |  |  |  |  |  |
| 4733 | 1641.3.5 | CT1 part of CT aspects of Extended IMS media plane security features | 463d? | 2012-12-13 A | 2014-09-11 A | 100% | 2012-12-13 | 2014-09-12 | 463d? | finish no earlier than 2014-09-12 | C1 | 3696h | 3696h | eMEDIASEC-CT | 30 | 23.218; 24.147; 24.229; 24.247 | Alcatel-Lucent | Rel-12 | 58 | Frederic |  |  |  |  |  |
| 4734 | 1641.3.6 | (IETF) CT1 part of Extended IMS media plane security features (RFC 7345) | 137d? | 2014-03-06 A | 2014-09-11 A | 100% | 2014-03-06 | 2014-12-05 | 197d? | finish no earlier than 2014-09-11 | C1-IETF | 1096h | 1096h | eMEDIASEC-CT | 32 | RFC 7345 (was draft-ietf-mmusic-udptl-dtls) | christer.holmberg@ericsson.com | Rel-12 | 62 |  |  |  |  |  |  |
| 4735 | 1641.3.7 | CT3 part of CT aspects of Extended IMS media plane security features | 521d? | 2012-12-19 A | 2014-12-09 A | 100% | 2012-12-19 | 2014-06-13 | 394d? | finish no earlier than 2014-12-09 | C3 | 4168h | 4168h | eMEDIASEC-CT | 30 | 29.162 | Alcatel-Lucent | Rel-12 | 58 | Adrian |  |  |  |  | CP-140569 |
| 4736 | 1642 | Lawful Interception in the 3GPP Rel-12 | 592d? | 2012-09-17 A | 2014-12-12 A | 100% | 2012-09-17 | 2014-09-12 | 526d? | finish no earlier than 2014-12-12 | S3 | 4736h | 4736h | LI12 | 29 | 33.106; 33.107; 33.108 | PIDS, Alcatel-Lucent | Rel-12 | 57 | Mirko | LI12 |  |  |  |  |

Notes:
- 4712: Specify Stage 3 procedures to support the ULI signalling optimizations / WI rapporteur e-mail: horst.brinkmann@alcatel-lucent.com
- 4713: CP#64 completed / WI rapporteur e-mail: horst.brinkmann@alcatel-lucent.com
- 4714: CP#65 completed / WI rapporteur e-mail: horst.brinkmann@alcatel-lucent.com
- 4715: SEC12 is an umbrella Feature for Security related TEI12 type of changes that are not part of any other dedicated feature
- 4716: - / WI rapporteur e-mail: john.mattsson@ericsson.com
- 4717: SP#57 completed. Specify reqs to protect against false PWS Warning Notifications (Optional as not all regions/countries require this functionality). WID covers all objectivES in CP-150SA3 PWS_Sec Feature-level WID replacing the original Stage 1 UID_510154 / WI rapporteur e-mail: adrian.neal@vodafone.com
- 4718: SP#65 completed. TR 33.969v100 for 1-step Approval. Former TR 33.869 changed to 33.969. / WI rapporteur e-mail: john.mattsson@ericsson.com
- 4719: SP#64 stopped / WI rapporteur e-mail: john.mattsson@ericsson.com
- 4720: Completed in Rel-9 under PWS. SP#55 stopped, Stage 1 requirements removed from Rel-9 onwards (SP-120172). AP 55/1: SA1 to align Stage 1 PWS security for Rel-12. SA1 new WID PWS Security UID_560029. / WI rapporteur e-mail: john.mattsson@ericsson.com
- 4721: SP#53 work stopped as already done in previous releases / WI rapporteur e-mail: john.mattsson@ericsson.com
- 4722: TSG#56 work stopped. SP#56 updated WID SP-110223=>SP-120334 (removed all but SA3 impacted specs) / WI rapporteur e-mail: mikael.wass@ericsson.com
- 4723: RP#53 work stopped as no WI in RAN / WI rapporteur e-mail: john.mattsson@ericsson.com
- 4724: SP#60 completed / WI rapporteur e-mail: Silke.Holtmanns@nokia.com
- 4725: Triggered by Rel-11 TR 33.829 Study on Extended IMS media plane security features (FS_eMEDIASEC) / WI rapporteur e-mail: Aguibou.Barry@vodafone.com
- 4726: SP#64 completed / WI rapporteur e-mail: Aguibou.Barry@vodafone.com
- 4727: SP#65 completed / WI rapporteur e-mail: christer.holmberg@ericsson.com
- 4728: - / WI rapporteur e-mail: bruno.landais@alcatel-lucent.com
- 4729: CP#65 completed. TR 29.828v200 for Approval. 2/4/15: acronym changed to eMEDIASEC-CT / WI rapporteur e-mail: bruno.landais@alcatel-lucent.com
- 4730: CP#65 completion 09/14=>12/14. Exception in CP-140479. Dec.14: 90->100. 2/4/15: acronym changed to eMEDIASEC-CT / WI rapporteur e-mail: bruno.landais@alcatel-lucent.com
- 4731: CP#65 completed. 2/4/15: acronym changed to eMEDIASEC-CT / WI rapporteur e-mail: christer.holmberg@ericsson.com
- 4732: Work in progress. 2/4/15: acronym changed to eMEDIASEC-CT¦22/3/18: 100%->0; 2/4/24: 50%->100 / WI rapporteur e-mail: christer.holmberg@ericsson.com
- 4733: CP#65 completed. 2/4/15: acronym changed to eMEDIASEC-CT / WI rapporteur e-mail: bruno.landais@alcatel-lucent.com
- 4734: CP#65 completed. 2/4/15: acronym changed to eMEDIASEC-CT / WI rapporteur e-mail: christer.holmberg@ericsson.com
- 4735: CP#65 completion 06/14=>12/14. Level 100%=>80%. Exception in CP-140569. CP#64 completed. Dec.14: 80->100. 2/4/15: acronym changed to eMEDIASEC-CT / WI rapporteur e-mail: bruno.landais@alcatel-lucent.com
- 4736: 3/3/15: 75->100% / WI rapporteur e-mail: Koen Jaspers (k.b.jaspers@minjus.nl), terry.jacobson@alcatel-lucent.com

| ID | WBS | Task | Duration | Start | Finish | Complete | Baseline start | Baseline finish | Baseline duration | Constraint | Resources | Work | Actual work | Acronym | PCG approved | WI rapporteur name | WI rapporteur e-mail | Release | TSG approved | MCC resp | Acronym_3GU_Export | Status Report |
| --- | --- | --- | --- | --- | --- | --- | --- | --- | --- | --- | --- | --- | --- | --- | --- | --- | --- | --- | --- | --- | --- | --- |
| 4737 | 1643 | **Tunneling of UE Services over Restrictive Access Networks (Stage 2/3)** | 401d? | 2012-12-13 A | 2014-06-18 A | 100% | 2012-12-13 | 2014-06-18 | 401d? |  | S3; C1 | 11662.5h | 11662.5h | TURAN | 30 | Acme Packet | Prashant Kumar (PKumar@acmepacket.com) | Rel-12 | 58 | Mirko | TURAN |  |
| 4738 | 1643.1 | SA3 part of Tunneling of UE Services over Restrictive Access Networks (Stage 2/3) | 400d? | 2012-12-13 A | 2014-06-18 A | 100% | 2012-12-13 | 2014-06-18 | 400d? | finish no earlier than 2014-06-18 | S3 | 3168h | 3168h | TURAN-SA3 | 30 | Acme Packet | Prashant Kumar (PKumar@acmepacket.com) | Rel-12 | 58 | Mirko |  |  |
| 4739 | 1643.2 | CT aspects of Tunneling of UE Services over Restrictive Access Networks (Stage 3) | 264d? | 2013-06-14 A | 2014-06-13 A | 100% | 2013-06-14 | 2014-06-13 | 264d? | finish no earlier than 2014-06-13 | C1 | 2094.45h | 2094.45h | TURAN-CT | 31 | Huawei | Haitao Wei (weihaitao@huawei.com) | Rel-12 | 60 | Frederic | TURAN-CT |  |
| 4740 | 1644 | Specification of the TUAK Algorithm Set | 139d? | 2013-12-09 A | 2014-06-18 A | 100% | 2013-12-09 | 2014-06-18 | 139d? | finish no earlier than 2014-06-18 | S3 | 1112h | 1112h | STAS | 32 | Vodafone | aguibou.barry@vodafone.com | Rel-12 | 62 | Mirko | STAS |  |
| 4741 | 1645 | **Codec for Enhanced Voice Services** | 1575d? | 2010-03-25 A | 2016-03-15 A | 100% | 2010-03-25 | 2014-12-12 | 1245d? |  | S4; S1; C4; C1; C3 | 87912h | 87912h | EVS_codec | 24 | Huawei | lei.miao@huawei.com | Rel-12 | 47 | Paolo | EVS_codec |  |
| 4742 | 1645.1 | Stage 1 for Codec for Enhanced Voice Services | 1d? | 2010-03-25 A | 2010-03-25 A | 100% | 2010-03-25 | 2010-03-25 | 1d? | start no earlier than 2010-03-25 | S1 | 8h | 8h | EVS_codec-SA1 | 24 | Huawei | lei.miao@huawei.com | Rel-12 | 47 | Paolo |  |  |
| 4743 | 1645.2 | Stage 2/3 for Codec for Enhanced Voice Services | 1240d? | 2010-03-25 A | 2014-12-12 A | 100% | 2010-03-25 | 2014-09-17 | 1178d? | finish no earlier than 2014-12-12 | S4 | 9896h | 9896h | EVS_codec-SA4 | 24 | Huawei | lei.miao@huawei.com | Rel-12 | 47 | Paolo |  | SP-140467 |
| 4744 | 1645.3 | TR on Performance characterization of Codec for Enhanced Voice Services | 1239d? | 2010-03-25 A | 2014-12-12 A | 100% | 2010-03-25 | 2014-12-12 | 1239d? | finish no earlier than 2014-12-12 | S4 | 9888h | 9888h | EVS_codec-SA4TR | 24 | Huawei | lei.miao@huawei.com | Rel-12 | 47 | Paolo |  | SP-140467 |
| 4745 | 1645.4 | **CT impacts of codec for Enhanced Voice Services** | 63d? | 2014-09-16 A | 2014-12-09 A | 100% |  |  |  |  | C4; C1; C3 | 3024h | 3024h | EVS_codec-CT | 33 | Nokia Networks | Jan.Kall@nsn.com | Rel-12 | 65 |  | EVS_codec-CT |  |
| 4746 | 1645.4.1 | CT4 part of CT impacts of codec for Enhanced Voice Services | 63d? | 2014-09-16 A | 2014-12-09 A | 100% |  |  |  | finish no earlier than 2014-12-09 | C4 | 504h | 504h | EVS_codec-CT | 33 | Nokia Networks | Jan.Kall@nsn.com | Rel-12 | 65 |  |  | CP-140478 |
| 4747 | 1645.4.2 | CT1 part of CT impacts of codec for Enhanced Voice Services | 63d? | 2014-09-16 A | 2014-12-09 A | 100% |  |  |  | finish no earlier than 2014-12-09 | C1 | 504h | 504h | EVS_codec-CT | 33 | Nokia Networks | Jan.Kall@nsn.com | Rel-12 | 65 |  |  | CP-140618 |
| 4748 | 1645.4.3 | CT3 part of CT impacts of codec for Enhanced Voice Services | 63d? | 2014-09-16 A | 2014-12-09 A | 100% |  |  |  | finish no earlier than 2014-12-09 | C3 | 504h | 504h | EVS_codec-CT | 33 | Nokia Networks | Jan.Kall@nsn.com | Rel-12 | 65 |  |  | CP-140560 |
| 4749 | 1645.5 | UE Conformance Test Aspects - Codec for Enhanced Voice Services (EVS) | 262d? | 2015-03-16 A | 2016-03-15 A | 100% |  |  |  | finish no earlier than 2016-03-15 | R5 | 2096h | 2096h | EVS_codec-UEConTest | 34 | Ericsson |  | Rel-12 | 67 |  |  | RP-151164 |
| 4750 | 1646 | **Coordination of Video Orientation** | 400d? | 2012-06-07 A | 2013-12-06 A | 100% | 2012-06-07 | 2013-12-06 | 400d? |  | S4; C4; C1; C3 | 20496.8h | 20496.8h | CVO | 29 | Ericsson | frederic.gabin@ericsson.com | Rel-12 | 56 | Paolo | CVO |  |
| 4751 | 1646.1 | SA4 part of Coordination of Video Orientation | 196d? | 2012-06-07 A | 2013-03-06 A | 100% | 2012-06-07 | 2013-03-06 | 196d? | finish no earlier than 2013-03-06 | S4 | 1560h | 1560h | CVO-SA4 | 29 | Ericsson | frederic.gabin@ericsson.com | Rel-12 | 56 | Paolo |  |  |
| 4752 | 1646.2 | **CT aspects of Coordination of Video Orientation** | 129d? | 2013-06-14 A | 2013-12-06 A | 100% | 2013-06-14 | 2013-12-06 | 129d? |  | C4; C1; C3 | 6136.8h | 6136.8h | CVO-CT | 31 | Ericsson | nevenka.biondic@ericsson.com | Rel-12 | 60 | Kimmo | CVO-CT |  |
| 4753 | 1646.2.1 | CT4 part of CT aspects of Coordination of Video Orientation | 128.05d? | 2013-06-14 A | 2013-12-06 A | 100% | 2013-06-14 | 2013-12-06 | 128.05d? | finish no earlier than 2013-12-06 | C4 | 1008.4h | 1008.4h | CVO-CT | 31 | Ericsson | nevenka.biondic@ericsson.com | Rel-12 | 60 | Kimmo |  |  |
| 4754 | 1646.2.2 | CT1 part of CT aspects of Coordination of Video Orientation | 129d? | 2013-06-14 A | 2013-12-06 A | 100% | 2013-06-14 | 2013-12-06 | 129d? | finish no earlier than 2013-12-06 | C1 | 1016h | 1016h | CVO-CT | 31 | Ericsson | nevenka.biondic@ericsson.com | Rel-12 | 60 | Frederic |  |  |
| 4755 | 1646.2.3 | CT3 part of CT aspects of Coordination of Video Orientation | 127.05d? | 2013-06-14 A | 2013-12-06 A | 100% | 2013-06-14 | 2013-12-06 | 127.05d? | finish no earlier than 2013-12-06 | C3 | 1016.4h | 1016.4h | CVO-CT | 31 | Ericsson | nevenka.biondic@ericsson.com | Rel-12 | 60 | Adrian |  |  |
| 4756 | 1647 | **High Efficiency Video Coding** | 594d? | 2012-09-12 A | 2014-12-05 A | 100% | 2012-09-12 | 2014-12-05 | 591d? |  | S4; IETF | 21576h | 21576h | HEVC | 29 | Qualcomm | Ye-Kui Wang (yekuiw@qti.qualcomm.com) | Rel-12 | 57 | Paolo | HEVC |  |
| 4757 | 1647.1 | TR on Evaluation of High Efficiency Video Coding for 3GPP Services | 464d? | 2012-09-12 A | 2014-06-19 A | 100% | 2012-09-12 | 2014-06-19 | 464d? | finish no earlier than 2014-06-18 | S4 | 3704h | 3704h | HEVC-SA4TR | 29 | Qualcomm | Ye-Kui Wang (yekuiw@qti.qualcomm.com) | Rel-12 | 57 | Paolo |  |  |
| 4758 | 1647.2 | High Efficiency Video Coding in 3GPP services PSS, MBMS, DASH, MMS, MTSI, IMS Messaging and Presence | 462d? | 2012-09-17 A | 2014-06-18 A | 100% | 2012-09-17 | 2014-06-18 | 462d? | finish no earlier than 2014-06-18 | S4 | 3688h | 3688h | HEVC-SA4 | 29 | Qualcomm | Ye-Kui Wang (yekuiw@qti.qualcomm.com) | Rel-12 | 57 | Paolo |  |  |
| 4759 | 1647.3 | (IETF) High Efficiency Video Coding | 587d? | 2012-09-17 A | 2014-12-05 A | 100% | 2012-09-17 | 2014-12-05 | 587d? | finish no earlier than 2014-12-05 | S4-IETF | 4696h | 4696h | HEVC-SA4IETF | 32 | Thomas Stockhammer, Qualcomm Incorporated | tsto@qti.qualcomm.com | Rel-12 | 63 |  |  |  |
| 4760 | 1648 | Mobile stereoscopic 3D services extensions | 200d? | 2012-12-12 A | 2013-09-11 A | 100% | 2012-12-12 | 2013-09-11 | 200d? | finish no earlier than 2013-09-11 | S4 | 1568h | 1568h | M3DV_Ext | 30 | Huawei | lukasz.kondrad@huawei.com | Rel-12 | 58 | Paolo | M3DV_Ext |  |

Notes:
- 4737: Linked to Rel-12 SMURFs. Related to TS 22.278 (EPS) cl.7.1.8 Service Reachability (Firewall traversal for IP based services for non-3GPP access), TS 22.228 (IMS) cl.5 (support Firewall traversal), TR 33.830 (Study on Firewall traversal) / Impacted TSs and TRs: Stage 2/3
- 4738: SP#64 completed / Impacted TSs and TRs: 33.203; 33.402
- 4739: CP#64 completed. Stage 3 for 2 new SA3 solutions for firewall traversal: 1) UE access to PLMN IP-based services via restrictive non-3GPP Ans, 2) UE access to IMS services via restrictive ANs / Impacted TSs and TRs: 24.229; 24.302; New 24.322
- 4740: SP#64 completed. Triggered by SP-130602 LS from ETSI SAGE (TUAK as alternative to Milenage). 12/14: new TS added / Impacted TSs and TRs: New TSs: 35.231; 35.232; 35.233; 35.9nn; 35.9nn; 35.9nn
- 4741: Triggered by UID_370045 Study on enhanced voice service requirements for EPS (TR 22.813)
- 4742: SP#47 completed / Impacted TSs and TRs: 22.173
- 4743: SP#65 completion 09/14=>12/14. Exception in SP-140467. TS 26.441v200 for Approval. TSs 26.442/44/45/46/47/48/49/50/51v100 for 1-step Approval. Ongoing TS 26.443 EVS Codec ANSI C code (floating point). Dec.14: 90->95 / Impacted TSs and TRs: 26.114; New (26.441; 26.442; 26.443; 26.444; 26.445; 26.446; 26.447; 26.448; 26.449; 26.450; 26.451)
- 4744: SP#65 completion 09/14=>12/14. Ongoing TR 26.952 EVS Codec Performance Characterization. Exception in SP-140467 / Impacted TSs and TRs: New 26.952
- 4745: Stage 3¦WID: CP-140492-> CP-140800
- 4746: CP#65 exception in CP-140478. Dec.14: 0->100¦WID: CP-140492-> CP-140800 / Impacted TSs and TRs: 23.334; 29.232; 29.238; 29.332; 29.333; 29.334
- 4747: CP#65 exception in CP-140618. Dec.14: 0->100%¦WID: CP-140492-> CP-140800 / Impacted TSs and TRs: 24.229
- 4748: CP#65 exception in CP-140560. Dec.14: 20->100¦WID: CP-140492-> CP-140800 / Impacted TSs and TRs: 29.163; 29.292
- 4749: 03/07/15: Compl:0%->25% 03/07/15: WID: RP-150137->RP-150836 03/07/15: Stat Rep: ->RP-150831 29/09/15: Compl:25%->75% 29/09/15: Stat Rep: RP-150831->RP-1511641/1/16: Compl:75%->95%1/1/16: CD:Tue 15/12/15->Tue 15/03/16;
- 4750: CP#62 completed. Resolve backward compatible video orientation mis-alignment in MTSI real-time video communication via interaction between MTSI video clients at call setup & during mid-call of the video orientation for correct local rendering
- 4751: SP#59 completed. Resolve backward compatible video orientation mis-alignment in MTSI real-time video communication via interaction between MTSI video clients at call setup & during mid-call of the video orientation for correct local rendering / Impacted TSs and TRs: 26.114; 26.141; 26.234; 26.346
- 4752: Complete CVO support (both, basic 2 bit orientation and additional option for extra 6 bit granularity) within CN protocols/procedures for IMS nodes, e.g. IMS ALG/AGW,IBCF/TrGW,MRFC/MRFP & add support of CVO-related SDP attributes to be negotiated by UE / Impacted TSs and TRs: Stage 2/3
- 4753: CP#62 completed / Impacted TSs and TRs: 23.333; 23.334; 29.238; 29.332; 29.333; 29.334
- 4754: CP#62 completed / Impacted TSs and TRs: 24.229
- 4755: CP#62 completed / Impacted TSs and TRs: 29.162; 29.163
- 4756: Specify the support of HEVC in 3GPP services (PSS, DASH, MTSI, MMS, MBMS, IMS Messaging and Presence)
- 4757: SP#64 completed. TR 26.906v200 for Approval / Impacted TSs and TRs: New 26.906
- 4758: SP#64 completed / Impacted TSs and TRs: 26.114; 26.140; 26.141; 26.234; 26.244; 26.247; 26.346
- 4759: Submitted to IESG for publication. 7/10/15: Rapporteur added¦7/3/16: 50%->95¦13/6/16: 95%->100 / Impacted TSs and TRs: draft-ietf-payload-rtp-h265=>RFC7798
- 4760: SP#61 completed. Related to Rel-11 Study On Mobile 3D Video Coding (FS_M3DVC) TR 26.905 and Rel-11 Mobile 3D Video Coding (M3DVC) / Impacted TSs and TRs: 26.114; 26.245; 26.247; 26.430

| ID | WBS | Task | Duration | Start | Finish | Complete | Baseline start | Baseline finish | Baseline duration | Constraint | Resources | Work | Actual work | Acronym | PCG approved | WI rapporteur name | WI rapporteur e-mail | Release | TSG approved | MCC resp | Acronym_3GU_Export | Impacted TSs and TRs | Status Report | Special Focus Doc |
| --- | --- | --- | --- | --- | --- | --- | --- | --- | --- | --- | --- | --- | --- | --- | --- | --- | --- | --- | --- | --- | --- | --- | --- | --- |
| 4761 | 1649 | **IMS-based Streaming and Download Delivery Enhancements** | 329d? | 2012-12-12 A | 2014-03-07 A | 100% | 2012-12-12 | 2014-03-07 | 329d? |  | S4 | 7800h | 7800h | IMS_SDE | 30 | Intel | ozgur.oyman@intel.com | Rel-12 | 58 | Paolo | IMS_SDE |  |  |  |
| 4762 | 1649.1 | TR on IMS-based Streaming and Download Delivery Enhancements | 326d? | 2012-12-12 A | 2014-03-07 A | 100% | 2012-12-12 | 2014-03-07 | 326d? | finish no earlier than 2014-03-07 | S4 | 2584h | 2584h | IMS_SDE-SA4TR | 30 | Intel | ozgur.oyman@intel.com | Rel-12 | 58 | Paolo |  | new 26.827 |  |  |
| 4763 | 1649.2 | Specification on IMS-based Streaming and Download Delivery Enhancements | 327d? | 2012-12-13 A | 2014-03-07 A | 100% | 2012-12-13 | 2014-03-07 | 327d? | finish no earlier than 2014-03-07 | S4 | 2584h | 2584h | IMS_SDE-SA4 | 30 | Intel | ozgur.oyman@intel.com | Rel-12 | 58 | Paolo |  | 26.237 |  |  |
| 4764 | 1650 | **Acoustic Requirements and Test methods for IMS-based conversational speech services over LTE** | 532d? | 2012-12-12 A | 2014-12-12 A | 100% | 2012-12-12 | 2014-09-17 | 467d? |  | S4 | 14224h | 14224h | ART_LTE | 30 | Qualcomm | Andre Schevciw (aschevci@qualcomm.com) | Rel-12 | 58 | Paolo | ART_LTE | Stage 3 |  |  |
| 4765 | 1650.1 | Acoustic Requirements and Test methods for IMS-based conversational speech services over LTE - NarrowBand and WideBand aspects | 265d? | 2012-12-12 A | 2013-12-11 A | 100% | 2012-12-12 | 2013-12-11 | 265d? | finish no earlier than 2013-12-11 | S4 | 2088h | 2088h | ART_LTE-NBWB | 30 | Sony Mobile Communications | Peter.Isberg@sony.com | Rel-12 | 58 | Paolo | ART_LTE-NBWB | 26.131; 26.132 |  |  |
| 4766 | 1650.2 | Acoustic Requirements and Test methods for IMS-based conversational speech services over LTE - UE Delay aspects | 462d? | 2012-12-12 A | 2014-09-17 A | 100% | 2012-12-12 | 2014-09-17 | 461d? | finish no earlier than 2014-09-17 | S4 | 3696h | 3696h | ART_LTE-UED | 30 | AT&T, Orange | luisa.marchetto@att.com, stephane.ragot@orange.com | Rel-12 | 58 | Paolo | ART_LTE-UED | 26.131; 26.132 |  |  |
| 4767 | 1650.3 | Acoustic Requirements and Test methods for IMS-based conversational speech services over LTE - Super wideband and fullband aspects | 523d? | 2012-12-12 A | 2014-12-12 A | 100% | 2012-12-12 | 2014-09-17 | 461d? | finish no earlier than 2014-12-12 | S4 | 4184h | 4184h | ART_LTE-SUPER | 30 | Sony Mobile Communications | peter.isberg@sonymobile.com | Rel-12 | 58 | Paolo | ART_LTE-SUPER | 26.131; 26.132 | SP-140470 |  |
| 4768 | 1651 | **MBMS Improvements** | 471d? | 2013-03-06 A | 2014-12-12 A | 100% | 2013-03-06 | 2014-09-17 | 406d? |  | S4 | 18584h | 18584h | MI | 30 | Ericsson | eric.turcotte@ericsson.com | Rel-12 | 59 | Paolo | MI |  | SP-140471 |  |
| 4769 | 1651.1 | TR on Enhanced MBMS Operation | 463d? | 2013-03-06 A | 2014-12-12 A | 100% | 2013-03-06 | 2014-09-17 | 401d? | finish no earlier than 2014-12-12 | S4 | 3704h | 3704h | MI-EMOTR | 30 | Huawei | Zhiming Li (lizhiming@huawei.com) | Rel-12 | 59 | Paolo |  | New 26.848 | SP-140471 |  |
| 4770 | 1651.2 | Enhanced MBMS Operation | 463d? | 2013-03-06 A | 2014-12-12 A | 100% | 2013-03-06 | 2014-09-17 | 401d? | finish no earlier than 2014-12-12 | S4 | 3704h | 3704h | MI-EMO | 30 | Huawei | Zhiming Li (lizhiming@huawei.com) | Rel-12 | 59 | Paolo | MI-EMO | 26.247; 26.346 | SP-140471 |  |
| 4771 | 1651.3 | TR on MBMS operation on Demand | 463d? | 2013-03-06 A | 2014-12-12 A | 100% | 2013-03-06 | 2014-09-17 | 401d? | finish no earlier than 2014-12-12 | S4 | 3704h | 3704h | MI-MooDTR | 30 | Qualcomm | Charles Lo (clo@qti.qualcomm.com) | Rel-12 | 59 | Paolo |  | New 26.849 | SP-140471 |  |
| 4772 | 1651.4 | MBMS operation on Demand | 463d? | 2013-03-06 A | 2014-12-12 A | 100% | 2013-03-06 | 2014-09-17 | 401d? | finish no earlier than 2014-12-12 | S4 | 3704h | 3704h | MI-MooD | 30 | Qualcomm | Charles Lo (clo@qti.qualcomm.com) | Rel-12 | 59 | Paolo | MI-MooD | 26.346 | SP-140471 |  |
| 4773 | 1652 | **End-to-End Multimedia Telephony Service for IMS (MTSI) extensions** | 667d? | 2013-03-06 A | 2015-09-14 A | 100% | 2013-03-06 | 2015-03-13 | 533d? |  | S4 | 32648h | 32648h | E2EMTSI | 30 | Ericsson | tomas.frankkila@ericsson.com | Rel-12 | 59 | Paolo | E2EMTSI | 26.114 |  |  |
| 4774 | 1652.1 | S4 aspects of End-to-End Multimedia Telephony Service for IMS (MTSI) extensions | 406d? | 2013-03-06 A | 2014-09-16 A | 100% | 2013-03-06 | 2015-03-13 | 533d? | finish no earlier than 2014-09-17 | S4 | 3248h | 3248h | E2EMTSI | 30 | Ericsson | tomas.frankkila@ericsson.com | Rel-12 | 59 | Paolo | E2EMTSI | 26.114 |  |  |
| 4775 | 1652.2 | **CT aspects of End-to-End Multimedia Telephony Service for IMS (MTSI) extensions** | 589d? | 2013-06-21 A | 2015-09-14 A | 100% | 2013-06-20 | 2014-09-12 | 326d? |  | C3; C1; C4 | 24064h | 24064h | E2EMTSI-CT | 31 | Ericsson | susana.fernandez@ericsson.com | Rel-12 | 60 | Adrian |  | Stage 2/3 |  |  |
| 4776 | 1652.2.1 | CT3 part of CT aspects of End-to-End Multimedia Telephony Service for IMS (MTSI) extensions | 589d? | 2013-06-21 A | 2015-09-14 A | 100% | 2013-06-20 | 2014-09-12 | 326d? | finish no earlier than 2015-09-14 | C3 | 4712h | 4712h | E2EMTSI-CT | 31 | Ericsson | susana.fernandez@ericsson.com | Rel-12 | 60 | Adrian |  | 29.162; 29.163; 29.213; 29.214 |  |  |
| 4777 | 1652.2.2 | CT1 part of CT aspects of End-to-End Multimedia Telephony Service for IMS (MTSI) extensions | 326d? | 2013-06-21 A | 2014-09-12 A | 100% | 2013-06-20 | 2014-09-12 | 326d? | finish no earlier than 2014-09-12 | C1 | 2608h | 2608h | E2EMTSI-CT | 31 | Ericsson | susana.fernandez@ericsson.com | Rel-12 | 60 | Frederic |  | 24.229 |  |  |
| 4778 | 1652.2.3 | CT4 part of CT aspects of End-to-End Multimedia Telephony Service for IMS (MTSI) extensions | 326d? | 2013-06-21 A | 2014-09-12 A | 100% | 2013-06-20 | 2014-09-12 | 326d? | finish no earlier than 2014-09-12 | C4 | 2608h | 2608h | E2EMTSI-CT | 31 | Ericsson | susana.fernandez@ericsson.com | Rel-12 | 60 | Kimmo |  | 23.333; 23.334; 29.238; 29.332; 29.333; 29.334 |  |  |
| 4779 | 1653 | Video Coding Enhancements in IMS Messaging and Presence | 64d? | 2013-12-11 A | 2014-03-07 A | 100% | 2013-12-11 | 2014-03-07 | 64d? | finish no earlier than 2014-03-07 | S4 | 504h | 504h | VCEIMP | 32 | Ericsson | frederic.gabin@ericsson.com | Rel-12 | 62 | Paolo | VCEIMP | 26.141 |  |  |
| 4780 | 1654 | Video Telephony Robustness Improvements | 66d? | 2014-06-18 A | 2014-09-16 A | 100% | 2014-06-18 | 2014-09-17 | 66d? | finish no earlier than 2014-09-17 | S4 | 528h | 528h | VTRI | 33 | Qualcomm | Muhammed Coban (mcoban@qti.qualcomm.com) | Rel-12 | 64 |  | VTRI | 26.114 |  |  |
| 4781 | 1655 | **Rel-12 Operations, Administration, Maintenance and Provisioning (OAM&P)** | 857d? | 2011-09-21 A | 2014-12-12 A | 100% | 2011-09-21 | 2014-09-17 | 792d? |  | S5 | 58352.5h | 58352.5h | OAM12 | 29 |  |  | Rel-12 | 56 | Mirko | OAM12 |  |  |  |
| 4782 | 1655.1 | **Rel-12 Self-Organizing Networks (SON) - OAM aspects** | 591d? | 2011-09-21 A | 2013-12-11 A | 100% | 2011-09-21 | 2013-12-11 | 591d? |  | S5 | 9408h | 9408h | OAM12-SON | 29 |  |  | Rel-12 | 56 | Mirko | OAM12-SON |  |  | HNB, SON |
| 4783 | 1655.1.1 | Multi-vendor Plug and Play eNB connection to the network | 586d? | 2011-09-21 A | 2013-12-11 A | 100% | 2011-09-21 | 2013-12-11 | 586d? | finish no earlier than 2013-12-11 | S5 | 4680h | 4680h | SON-NM-MUPPET | 29 | NSN | anatoly.andrianov@nsn.com | Rel-12 | 56 | Mirko | SON-NM-MUPPET | 32.501; New TSs (32.508; 32.509) |  | HNB, SON |
| 4784 | 1655.2 | **Compliance of 3GPP SA5 specifications to the NGMN Next Generation Converged Operations Requirements (NGCOR)** | 596d? | 2012-06-20 A | 2014-09-17 A | 100% | 2012-06-20 | 2014-09-17 | 595d? |  | S5 | 11616.5h | 11616.5h | OAM-NGMN_NGCOR | 29 | Huawei | christian.toche@huawei.com | Rel-12 | 56 | Mirko | OAM-NGMN_NGCOR |  |  |  |
| 4785 | 1655.2.1 | Converged Management Model Alignment (Phase 2) | 593d? | 2012-06-20 A | 2014-09-17 A | 100% | 2012-06-20 | 2014-09-17 | 593d? | finish no earlier than 2014-09-17 | S5 | 4744h | 4744h | OAM-MODAL | 29 | NSN | olaf.pollakowski@nsn.com | Rel-12 | 56 | Mirko | OAM-MODAL | 32.156; new 28.820 |  |  |
| 4786 | 1655.2.2 | 3GPP Fault Management Solution Profile for NGMN NGCOR | 266d? | 2012-06-20 A | 2013-06-19 A | 100% | 2012-06-20 | 2013-06-19 | 266d? | finish no earlier than 2013-06-19 | S5 | 2104.53h | 2104.53h | OAM-FMSP | 29 | Ericsson | thomas.tovinger@ericsson.com | Rel-12 | 56 | Mirko | OAM-FMSP | new 28.390 |  |  |

Notes:
- 4761: Provide an extension of IMS based PSS and MBMS user services
- 4762: SP#63 completed. Identify use cases and requirements based on Rel-10/11 PSS and MBMS functionality to be addressed for IMS-based streaming and download enhancements
- 4763: SP#63 completed. Develop procedures towards enabling the IMS-based extensions of the identified use casES in CP-150TS 26.237. Refine existing MBMS download procedures to enable IMS-based MBMS file repair with the use of conventional HTTP web servers.
- 4764: Triggered by Rel-12 Feature Codec for Enhanced Voice Services (EVS_codec) UID_470030. Need for super wideband acoustic requirements and test methods
- 4765: SP#62 completed
- 4766: SP#65 completed
- 4767: SP#65 completion 09/14=>12/14. Exception in SP-140470. Dec.14: 65->100
- 4768: Stage 3 based on existing Stage 2 in TS 23.246 MBMS Architecture and functional description
- 4769: SP#65 completion 09/14=>12/14. Exception in SP-140471. SP#63 TR 26.848v100 for Information. Dec.14: 85->100.
- 4770: SP#65 completion 09/14=>12/14. Exception in SP-140471. Dec.14: 85->100
- 4771: SP#65 completion 09/14=>12/14. Exception in SP-140471. SP#63 TR 26.849v100 for Information. Dec.14: 75->100
- 4772: SP#65 completion 09/14=>12/14. Exception in SP-140471. Dec.14: 75->100
- 4773: SP#65 completed. Updated WID SP-130670=>SP-140594. Reduced Scope & Objectives. Moved work on new TR 26.924, etc. to Rel-13. Co-ordinate with CT1/3/4. Linked to SA4 Rel-7 Media handling and interaction in MTSI (MTSI-MHI) UID_7040
- 4774: SP#65 completed. Updated WID SP-130670=>SP-140594. Reduced Scope & Objectives. Moved work on new TR 26.924, etc. to Rel-13. Co-ordinate with CT1/3/4. Linked to SA4 Rel-7 Media handling and interaction in MTSI (MTSI-MHI) UID_7040
- 4775: Stage 2/3. 5/5/15: corrected to be Rel-12. Nothing to be done in the end (covered by Rel-13 QOSE2EMTSI-CT), so 100%
- 4776: Dec.14: CD: 09/14->09/15. 5/5/15: corrected to be Rel-12. Nothing to be done in the end (covered by Rel-13 QOSE2EMTSI-CT), so 100%
- 4777: CP#64 completion 06/14=>09/14. 5/5/15: corrected to be Rel-12. Nothing to be done in the end (covered by Rel-13 QOSE2EMTSI-CT), so 100%
- 4778: CP#64 completion 06/14=>09/14. 5/5/15: corrected to be Rel-12. Nothing to be done in the end (covered by Rel-13 QOSE2EMTSI-CT), so 100%
- 4779: SP#63 completed. Linked to Rel-6 Media Codecs and Formats for IMS Messaging and Presence (PRESNC-COFIMP) UID_34025. Work item which gave rise to TS 26.141
- 4780: SP#65 completed. Linked to E2EMTSI (End-to-End Multimedia Telephony Service for IMS extensions). Add Reqs&guidelines for video telephony robustness to improve service perf. for PLI, Generic NACK, and FIR messages within overall bitrate limit
- 4781: OAM12 is an umbrella Feature for changes that are not part of any other dedicated feature/WI
- 4782: OAM12-SON is an umbrella BB also for SON related TEI12 type of changes that are not part of any other dedicated feature/WI
- 4783: SP#62 completed. TS 32.508v200 for Approval, TS 32.509v100 for 1-step Approval
- 4784: SP#65 moved to Rel-13 OAM-PMID (Converged management Performance Management Interface Definition) UID_560235
- 4785: SP#65 completed. TR 28.280v100 for 1-step Approval
- 4786: SP#60 completed. TS 28.390v200 for Approval

| ID | WBS | Task | Duration | Start | Finish | Complete | Baseline start | Baseline finish | Baseline duration | Constraint | Resources | Work | Actual work | Acronym | PCG approved | WI rapporteur name | WI rapporteur e-mail | Release | TSG approved | MCC resp | Special Focus Doc | Acronym_3GU_Export | Status Report | TSG stopped |
| --- | --- | --- | --- | --- | --- | --- | --- | --- | --- | --- | --- | --- | --- | --- | --- | --- | --- | --- | --- | --- | --- | --- | --- | --- |
| 4787 | 1655.3 | **Network Management for 3GPP Interworking WLAN** | 793d? | 2011-09-21 A | 2014-09-17 A | 100% | 2011-09-21 | 2014-06-18 | 727d? |  | S5 | 17232h | 17232h | OAM-IWLAN | 27 | China Mobile | Chengang@chinamobile.com, lijian@chinamobile.com | Rel-12 | 53 | Mirko | WLAN | OAM-IWLAN |  |  |
| 4788 | 1655.3.1 | Performance measurements part Network Management for 3GPP Interworking WLAN | 785d? | 2011-09-22 A | 2014-09-17 A | 100% | 2011-09-22 | 2014-06-18 | 720d? | finish no earlier than 2014-09-17 | S5 | 6272h | 6272h | OAM-IWLAN-SA5P | 27 | China Mobile | Chengang@chinamobile.com, lijian@chinamobile.com | Rel-12 | 53 | Mirko | WLAN |  |  |  |
| 4789 | 1655.3.2 | NIM part Network Management for 3GPP Interworking WLAN | 585d? | 2011-09-21 A | 2013-12-11 A | 100% | 2011-09-21 | 2013-12-11 | 585d? | finish no earlier than 2013-12-11 | S5 | 4672h | 4672h | OAM-IWLAN-SA5NM | 27 | China Mobile | Chengang@chinamobile.com, lijian@chinamobile.com | Rel-12 | 53 | Mirko | WLAN |  |  |  |
| 4790 | 1655.4 | **Rel-12 Network Infrastructure Management** | 267d? | 2013-12-11 A | 2014-12-12 A | 100% | 2013-12-11 | 2014-09-17 | 202d? |  | S5 | 5848h | 5848h | OAM12-NIM | 30 |  |  | Rel-12 | 58 | Mirko |  | OAM12-NIM |  |  |
| 4791 | 1655.4.1 | Alarm quality improvements | 263d? | 2013-12-11 A | 2014-12-12 A | 100% | 2013-12-11 | 2014-09-17 | 201d? | finish no earlier than 2014-12-12 | S5 | 2104h | 2104h | OAM-AMI-SA5 | 32 | TeliaSonera | tommy.berggren@teliasonera.com | Rel-12 | 62 | Mirko |  | OAM-AMI | SP-140544 |  |
| 4792 | 1655.4.2 | Radio Planning Tool (RPT) interface | 201d? | 2014-03-07 A | 2014-12-12 A | 100% | 2014-03-07 | 2014-09-17 | 139d? | finish no earlier than 2014-12-12 | S5 | 1608h | 1608h | OAM-RPTi-SA5 | 32 | Nokia Networks | olaf.pollakowski@nsn.com | Rel-12 | 63 | Mirko |  | OAM-RPTi | SP-140546 |  |
| 4793 | 1655.5 | Deleted - Rel-12 Performance Management | 328d? | 2013-06-21 A | 2014-09-16 A | 100% | 2013-06-21 | 2014-09-17 | 328d? |  | S5 | 2624h | 2624h | OAM12-PM | 30 |  |  | Rel-12 | 58 | Mirko |  | OAM12-PM |  | SP-69 |
| 4794 | 1655.6 | **OAM aspects of Network Sharing** | 267d? | 2013-12-11 A | 2014-12-12 A | 100% | 2013-12-11 | 2014-09-17 | 202d? |  | S5 | 6344h | 6344h | OAM-SHARE | 32 | Orange | jeanmichel.cornily@orange.com | Rel-12 | 62 | Mirko |  | OAM-SHARE | SP-140545 |  |
| 4795 | 1655.6.1 | OAM aspects of Network Sharing - Concepts and high-level requirements | 263d? | 2013-12-11 A | 2014-12-12 A | 100% | 2013-12-11 | 2014-09-17 | 201d? | finish no earlier than 2014-12-12 | S5 | 2104h | 2104h | OAM-SHARE-SA5c | 32 | Orange | jeanmichel.cornily@orange.com | Rel-12 | 62 | Mirko |  |  | SP-140545 |  |
| 4796 | 1655.6.2 | OAM aspects of Network Sharing - Impacts on existing specifications | 263d? | 2013-12-12 A | 2014-12-12 A | 100% | 2013-12-12 | 2014-09-17 | 201d? | finish no earlier than 2014-12-12 | S5 | 2104h | 2104h | OAM-SHARE-SA5imp | 32 | Orange | jeanmichel.cornily@orange.com | Rel-12 | 62 | Mirko |  |  | SP-140545 |  |
| 4797 | 1656 | **Rel-12 Charging** | 402d? | 2012-12-12 A | 2014-06-18 A | 100% | 2012-12-12 | 2014-06-18 | 402d? |  | S5 | 10112h | 10112h | CH12 | 29 |  |  | Rel-12 | 57 | Mirko |  | CH12 |  |  |
| 4798 | 1656.1 | Short Message Service - Service Center (SMS-SC) Offline Charging | 325d? | 2012-12-12 A | 2014-03-07 A | 100% | 2012-12-12 | 2014-03-07 | 325d? | finish no earlier than 2014-03-07 | S5 | 2592h | 2592h | SMS-SC-CH | 30 | Alcatel-Lucent | maryse.gardella@alcatel-lucent.com | Rel-12 | 58 | Mirko |  | SMS-SC-CH |  |  |
| 4799 | 1656.2 | Charging per IP - Connectivity Access Network (IP-CAN) Session (Stage 2/3) | 201d? | 2013-09-12 A | 2014-06-18 A | 100% | 2013-09-12 | 2014-06-18 | 201d? | finish no earlier than 2014-06-18 | S5 | 1608h | 1608h | CHIPS | 31 | Ericsson | david.shrader@ericsson.com | Rel-12 | 61 | Mirko |  | CHIPS |  |  |
| 4800 | 1656.3 | Charging using an Alternative Roaming Provider (Stage 2/3) | 202d? | 2013-09-12 A | 2014-06-18 A | 100% | 2013-09-12 | 2014-06-18 | 202d? | finish no earlier than 2014-06-18 | S5 | 1608h | 1608h | CHARP | 31 | Ericsson | david.shrader@ericsson.com | Rel-12 | 61 | Mirko |  | CHARP |  |  |
| 4801 | 1656.4 | Charging for IMS centralized service (ICS) control (Stage 2/3) | 137d? | 2013-12-11 A | 2014-06-18 A | 100% | 2013-12-11 | 2014-06-18 | 137d? | finish no earlier than 2014-06-18 | S5 | 1088h | 1088h | CHICS | 32 | NSN | Gerald.Goermer@nsn.com | Rel-12 | 62 | Mirko |  | CHICS |  |  |
| 4802 | 1657 | **IMS Emergency PSAP Callback (Stage 3)** | 724d? | 2011-09-21 A | 2014-06-13 A | 100% | 2011-09-21 | 2014-06-13 | 724d? |  | C1; C3; IETF | 38848h | 38848h | EMC_PC | 27 | Ericsson | christer.holmberg@ericsson.com | Rel-12 | 53 | Frederic | Public Safety (I-A) | EMC_PC |  |  |
| 4803 | 1657.1 | CT1 part of IMS Emergency PSAP Callback | 721d? | 2011-09-22 A | 2014-06-13 A | 100% | 2011-09-22 | 2014-06-13 | 721d? | finish no earlier than 2014-06-13 | C1 | 5760h | 5760h | EMC_PC | 27 | Ericsson | christer.holmberg@ericsson.com | Rel-12 | 53 | Frederic | Public Safety (I-A) |  |  |  |
| 4804 | 1657.2 | (IETF) CT1 part of IMS Emergency PSAP Callback (RFC 7090) | 723d? | 2011-09-21 A | 2014-06-13 A | 100% | 2011-09-21 | 2014-06-13 | 723d? | finish no earlier than 2014-06-13 | C1-IETF | 5776h | 5776h | EMC_PC | 27 | christer.holmberg@ericsson.com | christer.holmberg@ericsson.com | Rel-12 | 53 | Frederic | Public Safety (I-A) |  |  |  |
| 4805 | 1657.3 | CT3 part of IMS Emergency PSAP Callback | 519d? | 2011-09-24 A | 2013-09-06 A | 100% | 2011-09-24 | 2013-09-06 | 519d? | finish no earlier than 2013-09-06 | C3 | 4152h | 4152h | EMC_PC | 27 | Ericsson | christer.holmberg@ericsson.com | Rel-12 | 53 | Adrian | Public Safety (I-A) |  |  |  |
| 4806 | 1657.4 | (IETF) CT3 part of IMS Emergency PSAP Callback (RFC 7090) | 724d? | 2011-09-21 A | 2014-06-13 A | 100% | 2011-09-21 | 2014-06-13 | 724d? | finish no earlier than 2014-06-13 | C3-IETF | 5784h | 5784h | EMC_PC | 31 | christer.holmberg@ericsson.com | christer.holmberg@ericsson.com | Rel-12 | 60 | Adrian | Public Safety (I-A) |  |  |  |
| 4807 | 1658 | Interworking between a PLMN with WLAN to access the EPC and a PDN (Stage 3) | 265d? | 2012-09-10 A | 2013-09-06 A | 100% | 2012-09-10 | 2013-09-06 | 265d? | finish no earlier than 2013-08-12 | C3 | 2091.72h | 2091.72h | SAES_WLAN_EPC_intwk | 29 | Huawei | Christian.Herrero@huawei.com | Rel-12 | 57 | Adrian | WLAN | SAES_WLAN_EPC_intwk |  |  |
| 4808 | 1659 | **Reporting Enhancements in Warning Message Delivery (Stage 2/3)** | 402d? | 2012-12-07 A | 2014-06-13 A | 100% | 2012-12-07 | 2014-06-13 | 402d? |  | C1; C4; R3 | 20832.2h | 20832.2h | REP_WMD | 30 | one2many | peter.sanders@one2many.eu | Rel-12 | 58 | Frederic | Public Safety (I-A) | REP_WMD |  |  |
| 4809 | 1659.1 | CT1 part of Reporting Enhancements in Warning Message Delivery (Stage 2) | 329d? | 2012-12-07 A | 2014-03-04 A | 100% | 2012-12-07 | 2014-03-04 | 329d? | finish no earlier than 2014-03-06 | C1 | 2592.18h | 2592.18h | REP_WMD-CT1 | 30 | one2many | peter.sanders@one2many.eu | Rel-12 | 58 | Frederic | Public Safety (I-A) |  |  |  |
| 4810 | 1659.2 | CT4 part of Reporting Enhancements in Warning Message Delivery (Stage 2/3) | 400d? | 2012-12-10 A | 2014-06-13 A | 100% | 2012-12-10 | 2014-06-13 | 400d? | finish no earlier than 2014-06-13 | C4 | 3168h | 3168h | REP_WMD-CT4 | 30 | one2many | peter.sanders@one2many.eu | Rel-12 | 58 | Kimmo | Public Safety (I-A) |  |  |  |

Notes:
- 4787: SP#65 updated WID SP-120779=>SP-140542 (removed parts on CN and non-3GPP access). Discontinue I-WLAN spec.
- 4788: SP#65 completed. TS 28.402v100 for 1-step Approval, withdraw New TS 28.401 (CN and non-3GPP access i/w PMs). Moved PMs for EPC and non-3GPP access i/w from 28.401=>28.402 / Impacted TSs and TRs: new 28.401; withdrawn new 28.402
- 4789: SP#65 discontinue I-WLAN specs: Move parts (e.g. IOCs) applicable for EPC and non-3GPP access interworking NRMs from 28.601/2/6 to 28.611/2/6. Withdraw 28.601/2/6 (CN and non-3GPP access i/w NRMs). SP#62 completed. TSs 28.601/2/6/11/12/16 for Approval / Impacted TSs and TRs: 32.632; 32.636; 32.752; 32.756; new (28.611; 28.612; 28.616; withdrawn 28.601; 28.602; 28.606)
- 4790: -
- 4791: SP#65 completion 09/14=>12/14. Exception in SP-140544. Triggered by Rel-12 TR 32.859 Study on Alarm Management (FS_OAM_AM) . Dec.14: 50->100 / Impacted TSs and TRs: 32.111-1; 32.111-2; 32.111-6
- 4792: SP#65 completion 09/14=>12/14. Exception in SP-140546. SP#65 v100 TS 28.667/8 for Information. Dec.14: 60->100 / Impacted TSs and TRs: 32.101; New TSs (28.667; 28.668; 28.669)
- 4793: OAM12-PM is an umbrella BB also for PM related TEI12 type of changes that are not part of any other dedicated feature/WI
- 4794: SP#65 completion 09/14=>12/14. Exception in SP-140545. Triggered by Rel-12 TR 32.851 Study on OAM aspects of Network Sharing (FS_OAM_SHARE), Rel-6 Network Sharing (NTShar) UID_31018 / Impacted TSs and TRs: Stage 1/2/3
- 4795: SP#65 completion 09/14=>12/14. Exception in SP-140545. LM 80->100 / Impacted TSs and TRs: new 32.130
- 4796: SP#65 completion 09/14=>12/14. Exception in SP-140545. Dec.14: 60->100 / Impacted TSs and TRs: 28.401.28.621/2/3.28.651/2/3.28.654/5/6.28.657/8/9.28.701/2/3.28.731/2/3.28.734/5/6.32.101/2.32.111-1/2/3/6.32.121/2/6.32.155.32.171/2/6.32.300/1/2/6.32.311/2/6.32.321/2/6.32.331/2/6.32.341/2/6.32.351/352/6.32.361/2/6.32.381/2/6.32.405/6/7/8/9/10/11/12/41
- 4797: CH12 is an umbrella Feature for changes that are not part of any other dedicated feature/WI
- 4798: Stage 2/3. SP#63 completed. Updated WID SP-120775=>SP-140027 / Impacted TSs and TRs: 32.240; 32.274; 32.297; 32.298; 32.299
- 4799: SP#64 completed. 12/15: Acronym reverted back from CHIPCAN to CHIPS / Impacted TSs and TRs: 32.251; 32.298; 32.299
- 4800: SP#64 completed. TS 32.276v200 for Approval, 32.293v100 for 1-step Approval / Impacted TSs and TRs: 32.240; 32.299; New TSs [32.276 (Voice Call Service Charging); 32.293 (Proxy Function)]
- 4801: SP#64 completed. Align SA5 Charging specifications with Rel-8 Feature IMS Centralized Service control (ICSRA) and subsequent enhancements under TEIx (SA2 23.292 ICSRA Stage 2, CT3 29.292, CT1 24.607, 24.611) / Impacted TSs and TRs: 32.250; 32.298
- 4802: Dep. IETF ECRIT on PSAP call back. Fulfill SA1/2 Rel-7 EMC1 reqs UID_32045 PS domain and IMS impacts for supporting IMS Emergency calls (related to BB UID_1653 Emergency Call Enhancements for IP& PS Based Calls / Impacted TSs and TRs: Stage 3
- 4803: CP#64 completed. 2/4/15: acronym changed to EMC_PC / Impacted TSs and TRs: 24.229; tied to completion of IETF dependencies: 24.604; 24.605; 24.610; 24.611; 24.629
- 4804: CP#64 completed. 2/4/15: acronym changed to EMC_PC / Impacted TSs and TRs: RFC 7090 (was draft-ietf-ecrit-psap-callback
- 4805: CP#61 completed. 2/4/15: acronym changed to EMC_PC / Impacted TSs and TRs: 29.163; 29.165
- 4806: CP#64 completed. 2/4/15: acronym changed to EMC_PC / Impacted TSs and TRs: RFC 7090 (was draft-ietf-ecrit-psap-callback)
- 4807: CP#61 completed. Linked to Rel-8 Feature SAES in CP-150System Architecture Evolution specification - Evolved Packet System (non RAN aspects) UID_320005 / Impacted TSs and TRs: 29.061
- 4808: Stage 1 for Cell Broadcast does not exist. This WID enhances the reporting capabilities of Warning Message Delivery. Introduce LTE functionality requested by regulators, equivalent to existing 2G/3G functionality. / Impacted TSs and TRs: Stage 2/3
- 4809: CP#63 completed / Impacted TSs and TRs: 23.041
- 4810: CP#64 completed / Impacted TSs and TRs: 23.007; 29.168

| ID | WBS | Task | Duration | Start | Finish | Complete | Baseline start | Baseline finish | Baseline duration | Constraint | Resources | Work | Actual work | Acronym | PCG approved | WI rapporteur name | Release | TSG approved | MCC resp | Special Focus Doc | Acronym_3GU_Export | Status Report |
| --- | --- | --- | --- | --- | --- | --- | --- | --- | --- | --- | --- | --- | --- | --- | --- | --- | --- | --- | --- | --- | --- | --- |
| 4811 | 1659.3 | **Public Warning System - Reset/Failure/Restart in Warning Message Delivery in LTE** | 340d? | 2013-03-04 A | 2014-06-13 A | 100% | 2013-03-04 | 2014-06-13 | 340d? |  | R3 | 5424h | 5424h | REP_WMD-RFR_PWS | 30 | one2many, Huawei | Rel-12 | 59 | Juha | Public Safety (I-A) | REP_WMD-RFR_PWS |  |
| 4812 | 1659.3.1 | Core part: PWS - Reset/Failure/Restart in Warning Message Delivery in LTE | 338d? | 2013-03-04 A | 2014-06-13 A | 100% | 2013-03-04 | 2014-06-13 | 338d? | finish no earlier than 2014-06-13 | R3 | 2704h | 2704h | REP_WMD-RFR_PWS-Core | 30 | one2many, Huawei | Rel-12 | 59 | Juha | Public Safety (I-A) | REP_WMD-RFR_PWS-Core | RP-140637 |
| 4813 | 1660 | **Single Radio Voice Call Continuity (SRVCC) before ringing (Stage 3)** | 331d? | 2012-12-07 A | 2014-03-06 A | 100% | 2012-12-07 | 2014-03-06 | 331d? |  | C1; C3; R5 | 9584h | 9584h | bSRVCC | 30 | NTT DOCOMO | Rel-12 | 58 | Frederic |  | bSRVCC |  |
| 4814 | 1660.1 | CT1 part of Single Radio Voice Call Continuity (SRVCC) before ringing | 138d? | 2012-12-07 A | 2013-06-14 A | 100% | 2012-12-07 | 2013-06-14 | 138d? | finish no earlier than 2013-06-14 | C1 | 1096h | 1096h | bSRVCC | 30 | NTT DOCOMO | Rel-12 | 58 | Frederic |  |  |  |
| 4815 | 1660.2 | CT3 part of Single Radio Voice Call Continuity (SRVCC) before ringing | 3d? | 2013-06-12 A | 2013-06-14 A | 100% | 2013-06-12 | 2013-06-14 | 3d? | finish no earlier than 2013-06-14 | C3 | 24h | 24h | bSRVCC | 31 | NTT DOCOMO | Rel-12 | 60 | Adrian |  |  |  |
| 4816 | 1660.3 | Test part: Single Radio Voice Call Continuity (SRVCC) before ringing | 65d? | 2013-12-06 A | 2014-03-06 A | 100% | 2013-12-06 | 2014-03-06 | 65d? | finish no earlier than 2014-03-06 | R5 | 520h | 520h | bSRVCC-UEConTest | 32 | NTT DOCOMO | Rel-12 | 62 | Ingbert |  | bSRVCC-UEConTest | RP-140422 |
| 4817 | 1661 | **IMS Stage 3 IETF Protocol Alignment - phase 6** | 532d? | 2012-12-07 A | 2014-12-09 A | 100% | 2012-12-07 | 2014-12-05 | 527d? |  | C1; C3; IETF | 20640.6h | 20640.6h | IMSProtoc6 | 30 | Alcatel-Lucent | Rel-12 | 58 | Frederic |  | IMSProtoc6 |  |
| 4818 | 1661.1 | CT1 part of IMS Stage 3 IETF Protocol Alignment - phase 6 | 464d? | 2012-12-07 A | 2014-09-11 A | 100% | 2012-12-07 | 2014-09-12 | 464d? | finish no earlier than 2014-09-12 | C1 | 3712h | 3712h | IMSProtoc6 | 30 | Alcatel-Lucent | Rel-12 | 58 | Frederic |  |  |  |
| 4819 | 1661.2 | (IETF) CT1 part of IMS Stage 3 IETF Protocol Alignment - phase 6 (draft-holmberg-sipcore-received-realm) | 410d? | 2013-05-21 A | 2014-12-09 A | 100% | 2013-05-21 | 2014-12-05 | 408d? | finish no earlier than 2014-12-09 | C1-IETF | 3256.25h | 3256.25h | IMSProtoc6 | 31 | christer.holmberg@ericsson.com | Rel-12 | 60 | Frederic |  |  |  |
| 4820 | 1661.3 | Deleted - (IETF) CT1 part of IMS Stage 3 IETF Protocol Alignment - phase 6 (draft-jesske-sipcore-sip-tree-cap-indicators) | 63d? | 2014-09-12 A | 2014-12-05 A | 100% |  |  |  | finish no earlier than 2014-12-09 | C1-IETF | 504h | 504h | IMSProtoc6 | 33 | christer.holmberg@ericsson.com | Rel-12 | 65 |  |  |  |  |
| 4821 | 1661.4 | (IETF) CT1 part of IMS Stage 3 IETF Protocol Alignment - phase 6 (draft-ietf-insipid-session-id) | 65d? | 2014-09-12 A | 2014-12-09 A | 100% |  |  |  | start no earlier than 2014-09-12 | C1-IETF | 520h | 520h | IMSProtoc6 | 34 | christer.holmberg@ericsson.com | Rel-12 | 65 |  |  |  |  |
| 4822 | 1661.5 | CT3 part of IMS Stage 3 IETF Protocol Alignment - phase 6 | 71d? | 2014-06-06 A | 2014-09-11 A | 100% | 2014-06-06 | 2014-09-12 | 71d? | finish no earlier than 2014-09-12 | C3 | 568h | 568h | IMSProtoc6 | 30 | Alcatel-Lucent | Rel-12 | 58 | Adrian |  |  |  |
| 4823 | 1661.6 | (IETF) CT3 part of IMS Stage 3 IETF Protocol Alignment - phase 6 (draft-holmberg-sipcore-received-realm) | 327d? | 2013-09-06 A | 2014-12-05 A | 100% | 2013-09-06 | 2014-12-05 | 327d? | finish no earlier than 2014-12-05 | C3-IETF | 2608h | 2608h | IMSProtoc6 | 31 | christer.holmberg@ericsson.com | Rel-12 | 61 |  |  |  |  |
| 4824 | 1662 | **SAE Protocol Development - Phase 3** | 467d? | 2012-12-07 A | 2014-09-11 A | 100% | 2012-12-07 | 2014-09-12 | 467d? |  | C1 | 14920h | 14920h | SAES3 | 30 | InterDigital | Rel-12 | 58 | Frederic |  | SAES3 |  |
| 4825 | 1662.1 | SAE Protocol Development (Stage 3) - Phase 3 | 466d? | 2012-12-07 A | 2014-09-11 A | 100% | 2012-12-07 | 2014-09-12 | 466d? | finish no earlier than 2014-09-12 | C1 | 3728h | 3728h | SAES3-CT1 | 30 | InterDigital | Rel-12 | 58 | Frederic |  |  |  |
| 4826 | 1662.2 | CS Fallback in EPS - Phase 3 | 466d? | 2012-12-07 A | 2014-09-11 A | 100% | 2012-12-07 | 2014-09-12 | 466d? | finish no earlier than 2014-09-12 | C1 | 3728h | 3728h | SAES3-CSFB | 30 | InterDigital | Rel-12 | 58 | Frederic |  | SAES3-CSFB |  |
| 4827 | 1662.3 | SAE for support for non-3GPP accesses - Phase 3 | 466d? | 2012-12-07 A | 2014-09-11 A | 100% | 2012-12-07 | 2014-09-12 | 466d? | finish no earlier than 2014-09-12 | C1 | 3728h | 3728h | SAES3-non3GPP | 30 | InterDigital | Rel-12 | 58 | Frederic |  | SAES3-non3GPP |  |
| 4828 | 1663 | **IM-SSF Application Server Service Data Descriptions (Stage 2/3)** | 138d? | 2012-12-07 A | 2013-06-14 A | 100% | 2012-12-07 | 2013-06-14 | 138d? |  | C4; C1 | 3780h | 3780h | IMS_SSFDD | 30 | Huawei | Rel-12 | 58 | Kimmo |  | IMS_SSFDD |  |
| 4829 | 1663.1 | Stage 2 for IM-SSF Application Server Service Data Descriptions | 62d? | 2012-12-07 A | 2013-03-01 A | 100% | 2012-12-07 | 2013-03-01 | 62d? | finish no earlier than 2013-06-14 | C1 | 488h | 488h | IMS_SSFDD | 30 | Huawei | Rel-12 | 58 | Frederic |  |  |  |
| 4830 | 1663.2 | Stage 3 for IM-SSF Application Server Service Data Descriptions | 136.5d? | 2012-12-10 A | 2013-06-14 A | 100% | 2012-12-10 | 2013-06-14 | 136.5d? | finish no earlier than 2013-06-14 | C4 | 1084h | 1084h | IMS_SSFDD | 30 | Huawei | Rel-12 | 58 | Kimmo |  |  |  |
| 4831 | 1664 | **Diameter based interface between SGSN and SMS central functions (Stage 2/3)** | 265d? | 2012-12-10 A | 2013-12-06 A | 100% | 2012-12-10 | 2013-12-06 | 265d? |  | C4; C1 | 7952h | 7952h | Dia_SGSN_SMS | 30 | Alcatel-Lucent | Rel-12 | 58 | Kimmo |  | Dia_SGSN_SMS |  |
| 4832 | 1664.1 | Stage 2 for Diameter based interface between SGSN and SMS central functions | 201d? | 2013-03-07 A | 2013-12-06 A | 100% | 2013-03-07 | 2013-12-06 | 201d? | finish no earlier than 2013-12-06 | C1 | 1608h | 1608h | Dia_SGSN_SMS | 30 | Alcatel-Lucent | Rel-12 | 59 | Frederic |  |  |  |
| 4833 | 1664.2 | Stage 3 for Diameter based interface between SGSN and SMS central functions | 265d? | 2012-12-10 A | 2013-12-06 A | 100% | 2012-12-10 | 2013-12-06 | 265d? | finish no earlier than 2013-12-06 | C4 | 2104h | 2104h | Dia_SGSN_SMS | 30 | Alcatel-Lucent | Rel-12 | 58 | Kimmo |  |  |  |
| 4834 | 1665 | Diameter based interface between SGSN-GMLC (Stage 3) | 265d? | 2012-12-10 A | 2013-12-06 A | 100% | 2012-12-10 | 2013-12-06 | 265d? | finish no earlier than 2013-12-06 | C4 | 2096h | 2096h | Dia_SGSN_GMLC | 30 | Cisco | Rel-12 | 58 | Kimmo |  | Dia_SGSN_GMLC |  |
| 4835 | 1666 | IMS impacts on UICC Application Aspects (Stage 3) | 465d? | 2013-03-04 A | 2014-12-09 A | 100% | 2013-03-04 | 2014-09-12 | 403d? | finish no earlier than 2014-12-09 | C6 | 3720h | 3720h | IMS_UApAs | 30 | Giesecke & Devrient | Rel-12 | 59 | Xavier |  | IMS_UApAs | CP-140696 |

Notes:
- 4811: - / Impacted TSs and TRs: LTE / WI rapporteur e-mail: peter.sanders@one2many.eu, Dai Mingzeng (daimingzeng@huawei.com)
- 4812: RP#64 completed / Impacted TSs and TRs: 36.413 / WI rapporteur e-mail: peter.sanders@one2many.eu, Dai Mingzeng (daimingzeng@huawei.com)
- 4813: Linked to Rel-8 Feature IMS Service Continuity (IMS-Cont) UID_390056. TS 23.237 Rel-12 CR#0444 under TEI12 / Impacted TSs and TRs: GERAN; UTRA; LTE / WI rapporteur e-mail: keisuke.sasada.kx@nttdocomo.com
- 4814: CP#60 completed. 2/4/15: acronym changed to bSRVCC / Impacted TSs and TRs: 24.008; 24.237 / WI rapporteur e-mail: keisuke.sasada.kx@nttdocomo.com
- 4815: CP#60 completedbSRVCC / Impacted TSs and TRs: 29.165 / WI rapporteur e-mail: keisuke.sasada.kx@nttdocomo.com
- 4816: RP#63 completed. Testing for CT1 TS 24.237 (IMS service continuity Stage 3) / Impacted TSs and TRs: 34.229-1; 34.229-2; 36.523-1; 36.523-2 / WI rapporteur e-mail: Masahiro.Tamaoki.eu@nttdocomo.com
- 4817: - / Impacted TSs and TRs: Stage 3 / WI rapporteur e-mail: keith.drage@alcatel-lucent.com
- 4818: CP#65 completed. 4/2/15: acronym changed to IMSProtoc6 / Impacted TSs and TRs: 23.218; 24.229; 24.930 / WI rapporteur e-mail: keith.drage@alcatel-lucent.com
- 4819: Not completed internet-draft. 4/2/15: acronym changed to IMSProtoc6¦21/3/17: 50%->100 / Impacted TSs and TRs: draft-holmberg-sipcore-received-realm / WI rapporteur e-mail: christer.holmberg@ericsson.com
- 4820: Not completed internet-draft. 4/2/15: acronym changed to IMSProtoc6; 9/4/21: 25%->100 / Impacted TSs and TRs: draft-allen-sipcore-sip-tree-cap-indicators / WI rapporteur e-mail: christer.holmberg@ericsson.com
- 4821: work in progress. 4/2/15: acronym changed to IMSProtoc6¦21/3/17: 25%->100; 9/4/21: RFC 7989 added; / Impacted TSs and TRs: draft-ietf-insipid-session-id; RFC 7989
- 4822: CP#65 completed. 4/2/15: acronym changed to IMSProtoc6 / Impacted TSs and TRs: 29.163; 29.165 / WI rapporteur e-mail: keith.drage@alcatel-lucent.com
- 4823: Not completed internet-draft. 4/2/15: acronym changed to IMSProtoc6¦21/3/17: 50%->100 / Impacted TSs and TRs: draft-holmberg-sipcore-received-realm / WI rapporteur e-mail: christer.holmberg@ericsson.com
- 4824: Stage 3 continuation of Rel-8 Feature SAES (3GPP System Architecture Evolution Specification - Evolved Packet System) UID_320005 / Impacted TSs and TRs: Stage 2/3 / WI rapporteur e-mail: behrouz.aghili@interdigital.com
- 4825: CP#65 completed / Impacted TSs and TRs: 23.122; 24.008; 24.167; 24.229; 24.301; 24.302; 24.303; 24.304; 24.305; 24.312; 29.018; 29.118 / WI rapporteur e-mail: behrouz.aghili@interdigital.com
- 4826: CP#65 completed / Impacted TSs and TRs: 23.122; 24.008; 24.167; 24.229; 24.301; 24.302; 24.303; 24.304; 24.305; 24.312; 29.018; 29.118 / WI rapporteur e-mail: behrouz.aghili@interdigital.com
- 4827: CP#65 completed / Impacted TSs and TRs: 23.122; 24.008; 24.167; 24.229; 24.301; 24.302; 24.303; 24.304; 24.305; 24.312; 29.018; 29.118 / WI rapporteur e-mail: behrouz.aghili@interdigital.com
- 4828: CP#60 completed / Impacted TSs and TRs: Stage 2/3 / WI rapporteur e-mail: susan.shishufeng@huawei.com
- 4829: CP#59 completed / Impacted TSs and TRs: 23.218 / WI rapporteur e-mail: susan.shishufeng@huawei.com
- 4830: CP#60 completed / Impacted TSs and TRs: 29.328; 29.329; 29.364 / WI rapporteur e-mail: susan.shishufeng@huawei.com
- 4831: CP#62 completed / Impacted TSs and TRs: Stage 2/3 / WI rapporteur e-mail: jean-jacques.trottin@alcatel-lucent.com
- 4832: CP#62 completed / Impacted TSs and TRs: 23.040 / WI rapporteur e-mail: jean-jacques.trottin@alcatel-lucent.com
- 4833: CP#62 completed / Impacted TSs and TRs: 29.002; 29.230; 29.272; 29.305; 29.336; 29.337; 29.338 / WI rapporteur e-mail: jean-jacques.trottin@alcatel-lucent.com
- 4834: CP#62 completed. Updated WID CP-130273=>CP-130598. No Stage 2 impact. Define a Diameter variant for the protocol used over existing reference points between SGSN and GMLC for LCS (replace the use of MAP by Diameter protocol) / Impacted TSs and TRs: 29.002; 29.172; 29.173; 29.230; 29.272 / WI rapporteur e-mail: Nirav Salot (nsalot@cisco.com)
- 4835: CP#65 completion 09/14=>12/14. Exception in CP-140696. Dec.14: 85->100% / Impacted TSs and TRs: 31.102; 31.103; 31.111; 31.130 / WI rapporteur e-mail: sergi.espi@gi-de.com

| ID | WBS | Task | Duration | Start | Finish | Complete | Baseline start | Baseline finish | Baseline duration | Constraint | Resources | Work | Actual work | Acronym | PCG approved | Impacted TSs and TRs | WI rapporteur name | WI rapporteur e-mail | Release | TSG approved | MCC resp | Acronym_3GU_Export | Status Report |
| --- | --- | --- | --- | --- | --- | --- | --- | --- | --- | --- | --- | --- | --- | --- | --- | --- | --- | --- | --- | --- | --- | --- | --- |
| 4836 | 1667 | **eMBMS restoration procedures** | 406d? | 2013-03-01 A | 2014-09-11 A | 100% | 2013-03-01 | 2014-06-13 | 341d? |  | C4; C3 | 10272h | 10272h | eMBMS_Rest | 30 | Stage 3 | Alcatel-Lucent | bruno.landais@alcatel-lucent.com | Rel-12 | 59 | Kimmo | eMBMS_Rest |  |
| 4837 | 1667.1 | CT4 part of eMBMS restoration procedures | 205d? | 2013-03-01 A | 2013-12-06 A | 100% | 2013-03-01 | 2013-12-06 | 205d? | finish no earlier than 2013-12-06 | C4 | 1616h | 1616h | eMBMS_Rest | 30 | 23.007; 23.008; 29.274 | Alcatel-Lucent | bruno.landais@alcatel-lucent.com | Rel-12 | 59 | Kimmo |  |  |
| 4838 | 1667.2 | CT3 part of eMBMS restoration procedures | 270d? | 2013-09-04 A | 2014-09-11 A | 100% | 2013-09-04 | 2014-06-13 | 205d? | finish no earlier than 2014-09-12 | C3 | 2160h | 2160h | eMBMS_Rest | 31 | 29.061 | Alcatel-Lucent | bruno.landais@alcatel-lucent.com | Rel-12 | 61 | Kimmo |  |  |
| 4839 | 1668 | **Dual Radio VCC enhancements (Stage 2/3)** | 325d? | 2012-09-19 A | 2013-12-06 A | 100% | 2012-09-19 | 2013-12-06 | 325d? |  | C1; C3.S2 | 10866.2h | 10866.2h | eDRVCC | 30 | Stage 2/3 | Ericsson | Jan.Holm@ericsson.com | Rel-12 | 59 | Maurice | eDRVCC |  |
| 4840 | 1668.1 | Stage 2 for Dual Radio VCC enhancements | 57.55d? | 2012-09-19 A | 2013-03-01 A | 100% | 2012-09-19 | 2013-03-01 | 57.55d? | finish no earlier than 2013-03-01 | S2 | 460.4h | 460.4h | eDRVCC | 30 | 23.237 | Ericsson | Jan.Holm@ericsson.com | Rel-12 | 59 | Maurice |  |  |
| 4841 | 1668.2 | **Stage 3 for Dual Radio VCC enhancements** | 205d? | 2013-03-01 A | 2013-12-06 A | 100% | 2013-03-01 | 2013-12-06 | 205d? |  | C1; C3 | 5205.8h | 5205.8h | eDRVCC | 30 | Stage 3 | Ericsson | Jan.Holm@ericsson.com | Rel-12 | 59 | Frederic |  |  |
| 4842 | 1668.2.1 | CT1 part of Stage 3 for Dual Radio VCC enhancements | 205d? | 2013-03-01 A | 2013-12-06 A | 100% | 2013-03-01 | 2013-12-06 | 205d? | finish no earlier than 2013-12-06 | C1 | 1608h | 1608h | eDRVCC | 30 | 24.237; 24.292 | Ericsson | Jan.Holm@ericsson.com | Rel-12 | 59 | Frederic |  |  |
| 4843 | 1668.2.2 | CT3 part of Stage 3 for Dual Radio VCC enhancements | 41.7d? | 2013-03-01 A | 2013-09-06 A | 100% | 2013-03-01 | 2013-09-06 | 41.7d? | finish no earlier than 2013-09-06 | C3 | 317.8h | 317.8h | eDRVCC | 30 | 29.165 | Ericsson | Jan.Holm@ericsson.com | Rel-12 | 59 | Adrian |  |  |
| 4844 | 1669 | **CT aspects of Signalling of Image Size (Stage 2/3)** | 129d? | 2013-06-14 A | 2013-12-06 A | 100% | 2013-06-14 | 2013-12-06 | 129d? |  | C4; C1; C3 | 6136.8h | 6136.8h | SIS_CT | 31 | Stage 2/3 | Ericsson | nevenka.biondic@ericsson.com | Rel-12 | 60 | Kimmo | SIS_CT |  |
| 4845 | 1669.1 | CT4 part of Signalling of Image Size | 128.05d? | 2013-06-14 A | 2013-12-06 A | 100% | 2013-06-14 | 2013-12-06 | 128.05d? | finish no earlier than 2013-12-06 | C4 | 1008.4h | 1008.4h | SIS_CT | 31 | 23.333; 23.334; 29.238; 29.332; 29.333; 29.334 | Ericsson | nevenka.biondic@ericsson.com | Rel-12 | 60 | Kimmo |  |  |
| 4846 | 1669.2 | CT1 part of CT Aspects of Signalling of Image Size | 129d? | 2013-06-14 A | 2013-12-06 A | 100% | 2013-06-14 | 2013-12-06 | 129d? | finish no earlier than 2013-12-06 | C1 | 1016h | 1016h | SIS_CT | 31 | 24.229 | Ericsson | nevenka.biondic@ericsson.com | Rel-12 | 60 | Frederic |  |  |
| 4847 | 1669.3 | CT3 part of CT Aspects of Signalling of Image Size | 128.05d? | 2013-06-14 A | 2013-12-06 A | 100% | 2013-06-14 | 2013-12-06 | 128.05d? | finish no earlier than 2013-12-06 | C3 | 1016.4h | 1016.4h | SIS_CT | 31 | 29.162; 29.163 | Ericsson | nevenka.biondic@ericsson.com | Rel-12 | 60 | Adrian |  |  |
| 4848 | 1670 | IMS Centralized Services (ICS) InterWorking Enhancement in Mobile Switching Center Server (MSC-S) | 129d? | 2013-06-14 A | 2013-12-06 A | 100% | 2013-06-14 | 2013-12-06 | 129d? | finish no earlier than 2013-12-06 | C3 | 1008h | 1008h | ICS_IWE | 31 | 29.292 | Orange | marianne.mohali@orange.com | Rel-12 | 60 | Adrian | ICS_IWE |  |
| 4849 | 1671 | GPRS Tunnelling Protocol for the Control plane (GTP-C) Overload Control Mechanisms | 267d? | 2013-09-06 A | 2014-09-11 A | 100% | 2013-09-06 | 2014-09-12 | 267d? | finish no earlier than 2014-09-12 | C4 | 2136h | 2136h | GOCMe | 31 | 23.008; 29.230; 29.273; 29.274; 29.303; New 29.807 | Cisco | Nirav Salot (nsalot@cisco.com) | Rel-12 | 61 | Kimmo | GOCMe |  |
| 4850 | 1672 | **Proxy Call Session Control Function (P-CSCF) restoration enhancements (Stage 2/3)** | 447.1d? | 2013-04-03 A | 2014-12-09 A | 100% | 2013-04-03 | 2014-12-05 | 442.1d? |  | C4; C3; C1 | 54903.2h | 54903.2h | PCSCF_RES | 31 | Stage 2/3 | Ericsson | maria.cruz.bartolome@ericsson.com | Rel-12 | 61 | Kimmo | PCSCF_RES |  |
| 4851 | 1672.1 | TR on Proxy Call Session Control Function (P-CSCF) restoration enhancements | 266d? | 2013-09-06 A | 2014-09-11 A | 100% | 2013-09-06 | 2014-09-12 | 266d? | finish no earlier than 2014-09-12 | C4 | 2128h | 2128h | PCSCF_RES | 31 | New 29.806 | Ericsson | maria.cruz.bartolome@ericsson.com | Rel-12 | 61 | Kimmo |  |  |
| 4852 | 1672.2 | **Common for HSS & PCRF solutions** | 447.1d? | 2013-04-03 A | 2014-12-09 A | 100% |  |  |  |  | C4; C3; C1 | 18602.4h | 18602.4h | PCSCF_RES | 33 |  | Ericsson | maria.cruz.bartolome@ericsson.com | Rel-12 | 64 |  |  |  |
| 4853 | 1672.2.1 | CT4 part of Common for HSS & PCRF solutions | 328d? | 2013-09-06 A | 2014-12-09 A | 100% | 2013-09-06 | 2014-12-05 | 326d? | finish no earlier than 2014-12-09 | C4 | 2624h | 2624h | PCSCF_RES | 31 | 23.380; 29.060; 29.274 | Ericsson | maria.cruz.bartolome@ericsson.com | Rel-12 | 61 | Kimmo |  | CP-140481 |
| 4854 | 1672.2.2 | CT1 part of Common for HSS & PCRF solutions | 328d? | 2013-04-03 A | 2014-12-05 A | 100% | 2013-04-03 | 2014-12-05 | 326d? | finish no earlier than 2014-12-09 | C1 | 2624h | 2624h | PCSCF_RES | 33 | 24.008 | Ericsson | maria.cruz.bartolome@ericsson.com | Rel-12 | 64 | Kimmo |  |  |
| 4855 | 1672.2.3 | CT3 part of Common for HSS & PCRF solutions | 328d? | 2013-05-03 A | 2014-12-09 A | 100% | 2013-05-03 | 2014-12-05 | 326d? | finish no earlier than 2014-12-09 | C3 | 2624h | 2624h | PCSCF_RES | 33 | 29.061; 29.165 | Huawei | susan.shishufeng@huawei.com | Rel-12 | 65 | Kimmo |  | CP-140687 |
| 4856 | 1672.3 | **HSS based solution** | 447.1d? | 2013-04-03 A | 2014-12-09 A | 100% |  |  |  |  | C4; C1 | 12401.6h | 12401.6h | PCSCF_RES | 33 |  | Ericsson | maria.cruz.bartolome@ericsson.com | Rel-12 | 64 |  |  |  |
| 4857 | 1672.3.1 | CT4 part of HSS based solution | 328d? | 2013-09-06 A | 2014-12-09 A | 100% | 2013-09-06 | 2014-12-05 | 326d? | finish no earlier than 2014-12-09 | C4 | 2624h | 2624h | PCSCF_RES | 31 | 29.002; 29.228; 29.229; 29.272; 29.305 | Ericsson | maria.cruz.bartolome@ericsson.com | Rel-12 | 61 | Kimmo |  | CP-140481 |
| 4858 | 1672.3.2 | CT1 part of HSS based solution | 328d? | 2013-04-03 A | 2014-12-09 A | 100% | 2013-04-03 | 2014-12-05 | 326d? | finish no earlier than 2014-12-09 | C1 | 2624h | 2624h | PCSCF_RES | 33 | 24.229 | Ericsson | maria.cruz.bartolome@ericsson.com | Rel-12 | 64 | Kimmo |  | CP-140605 |
| 4859 | 1672.4 | **PCRF based solution** | 447.1d? | 2013-04-03 A | 2014-12-09 A | 100% |  |  |  |  | C3; C1 | 12401.6h | 12401.6h | PCSCF_RES | 33 |  | Huawei | susan.shishufeng@huawei.com | Rel-12 | 64 |  |  |  |
| 4860 | 1672.4.1 | CT3 part of PCRF based solution | 328d? | 2013-05-03 A | 2014-12-09 A | 100% | 2013-05-03 | 2014-12-05 | 326d? | finish no earlier than 2014-12-09 | C3 | 2624h | 2624h | PCSCF_RES | 33 | 29.212; 29.213; 29.214; 29.215 | Huawei | susan.shishufeng@huawei.com | Rel-12 | 64 | Kimmo |  | CP-140687 |
| 4861 | 1672.4.2 | CT1 part of PCRF based solution | 328d? | 2013-04-03 A | 2014-12-09 A | 100% | 2013-04-03 | 2014-12-05 | 326d? | finish no earlier than 2014-12-09 | C1 | 2624h | 2624h | PCSCF_RES | 33 | 24.229 | Huawei | susan.shishufeng@huawei.com | Rel-12 | 64 | Kimmo |  | CP-140605 |

Notes:
- 4836: CP#62 completed. Linked to Rel-9 MBMS support in EPS (MBMS_EPS). Rel-10 CT Features EPC Node Restoration with/out Idle mode Signalling Reduction (ISR) activated (EPC_NR/EPC_NR_ISR)
- 4837: CP#62 completed
- 4838: CP#65 completed
- 4839: CP#62 completed. Stage 2 in Rel-12 TEI12 TS 23.237 CR#0431, CR#0440, CR#0441, CR#0453 (pre-alerting). Stage 3 linked to Rel-8 Feature IMS Service Continuity (IMS-Cont) UID_390056 (Stage 2 in TS 23.237). 2/4/15: acronym changed to eDRVCC
- 4840: Stage 2 in Rel-12 TEI12 TS 23.237 CR#0431, CR#0440, CR#0441, CR#0453 (pre-alerting). 2/4/15: acronym changed to eDRVCC
- 4841: CP#62 completed
- 4842: CP#62 completed. 2/4/15: acronym changed to eDRVCC
- 4843: CP#61 completed. 2/4/15: acronym changed to eDRVCC
- 4844: CP#62 completed. SA4 Rel-8 MTSI Video: Dynamic Rate Adaptation/Signalling of Image Size UID_34041 has included service aspects to support image attribute (a=imageattr) in TS 26.114 as in RFC 6236. But associated CN aspects were not included
- 4845: CP#62 completed
- 4846: CP#62 completed
- 4847: CP#62 completed
- 4848: CP#62 completed. Stage 3 enhancement interworking between IMS and MSC-S for IMS Centralized Services (ICS)
- 4849: CP#65 completed. Updated WID CP-130433=>CP-140488
- 4850: CP#65 updated WID CP-140443=>CP-140490. Based TR 29.806, solutions B and D are selected for standardization. Dec.14: 95->100
- 4851: CP#65 completed. TR 29.806v200 for Approval
- 4852: -
- 4853: CP#65 completion 09/14=>12/14. Exception in CP-140481. Dec.14: 90->100
- 4854: CP#65 completed
- 4855: CP#65 updated WID CP-140443=>CP-140490 (added CT3 part). Exception in CP-140687
- 4856: -
- 4857: CP#65 completion 09/14=>12/14. Exception in CP-140481. Dec.14: 90->100
- 4858: CP#65 completion 09/14=>12/14. Exception in CP-140605. Dec.14: 65->100%
- 4859: -
- 4860: CP#65 updated WID CP-140443=>CP-140490 (added CT3 part). Exception in CP-140687
- 4861: CP#65 completion 09/14=>12/14. Exception in CP-140605. Dec.14: 65->100
