# Work_plan_3gpp_190315_Rel15_onwrds

Schedule from MS Project, 1999-01-01 to 2026-03-03, A marks actual dates.

| ID | WBS | Task | Duration | Start | Finish | Complete | Baseline start | Baseline finish | Baseline duration | Constraint | Resources | Work | Actual work | Acronym | PCG approved | WI rapporteur name | WI rapporteur e-mail | Release | TSG approved | MCC resp | Acronym_3GU_Export | Status Report |
| --- | --- | --- | --- | --- | --- | --- | --- | --- | --- | --- | --- | --- | --- | --- | --- | --- | --- | --- | --- | --- | --- | --- |
| 4862 | 1673 | **Updating IMS to conform to RFC 6665 (Stage 3)** | 400d? | 2013-09-09 A | 2015-03-13 A | 100% | 2013-09-09 | 2014-09-12 | 267d? |  | C1; C3 | 9576h | 9576h | UP6665 | 31 | BlackBerry | Andrew Allen (aallen@blackberry.com) | Rel-12 | 61 | Frederic | UP6665 |  |
| 4863 | 1673.1 | CT1 part of Updating IMS to conform to RFC 6665 | 329d? | 2013-09-09 A | 2014-12-09 A | 100% | 2013-09-09 | 2014-09-12 | 267d? | finish no earlier than 2014-12-09 | C1 | 2624h | 2624h | UP6665 | 31 | BlackBerry | Andrew Allen (aallen@blackberry.com) | Rel-12 | 61 | Frederic |  | CP-140620 |
| 4864 | 1673.2 | CT3 part of Updating IMS to conform to RFC 6665 | 66d? | 2013-09-09 A | 2013-12-06 A | 100% | 2013-09-09 | 2013-12-06 | 66d? | finish no earlier than 2013-12-06 | C3 | 528h | 528h | UP6665 | 31 | BlackBerry | Andrew Allen (aallen@blackberry.com) | Rel-12 | 61 | Maurice |  |  |
| 4865 | 1673.3 | (IETF) CT1 part of Updating IMS to conform to RFC 6665 (draft-ietf-sipcore-refer-clarifications) | 1d? | 2015-03-13 A | 2015-03-13 A | 100% |  |  |  |  | C1-IETF | 8h | 8h | UP6665 | 34 | BlackBerry | Andrew Allen (aallen@blackberry.com) | Rel-12 | 67 |  |  |  |
| 4866 | 1673.4 | (IETF) CT1 part of Updating IMS to conform to RFC 6665 (draft-ietf-sipcore-refer-explicit-subscription) | 1d? | 2015-03-13 A | 2015-03-13 A | 100% |  |  |  |  | C1-IETF | 8h | 8h | UP6665 | 34 | BlackBerry | Andrew Allen (aallen@blackberry.com) | Rel-12 | 67 |  |  |  |
| 4867 | 1673.5 | (IETF) CT1 part of Updating IMS to conform to RFC 6665 (draft-roach-sipcore-6665-clarifications) | 1d? | 2015-03-13 A | 2015-03-13 A | 100% |  |  |  |  | C1-IETF | 8h | 8h | UP6665 | 34 | BlackBerry | Andrew Allen (aallen@blackberry.com) | Rel-12 | 67 |  |  |  |
| 4868 | 1674 | **IMS Operator Determined Call Barring enhancements (Stage 3)** | 202d? | 2013-12-06 A | 2014-09-11 A | 100% | 2013-12-06 | 2014-06-13 | 137d? |  | C1; C3 | 5928h | 5928h | eIODB | 32 | Ericsson | Jorgen.Axell@ericsson.com | Rel-12 | 62 | Frederic | eIODB |  |
| 4869 | 1674.1 | CT1 part of IMS Operator Determined Call Barring enhancements | 136d? | 2013-12-06 A | 2014-06-13 A | 100% | 2013-12-06 | 2014-06-13 | 136d? | finish no earlier than 2014-06-13 | C1 | 1088h | 1088h | eIODB | 32 | Ericsson | Jorgen.Axell@ericsson.com | Rel-12 | 62 | Frederic |  |  |
| 4870 | 1674.2 | CT3 part of IMS Operator Determined Call Barring enhancements | 201d? | 2013-12-09 A | 2014-09-11 A | 100% | 2013-12-09 | 2014-06-13 | 136d? | finish no earlier than 2014-09-12 | C3 | 1608h | 1608h | eIODB | 32 | Ericsson | Jorgen.Axell@ericsson.com | Rel-12 | 62 | Adrian |  |  |
| 4871 | 1675 | Signalling Improvements for Network Efficiency (Stage 3) | 264d? | 2013-12-06 A | 2014-12-09 A | 100% | 2013-12-06 | 2014-09-12 | 202d? | finish no earlier than 2014-12-09 | C1 | 2112h | 2112h | SINE | 32 | Huawei | Lin Shu (shulin@huawei.com) | Rel-12 | 62 | Frederic | SINE | CP-140617 |
| 4872 | 1676 | **Interactive Connectivity Establishment (ICE, IETF RFC 5245) impacts on IMS H.248 profiles** | 138d? | 2014-03-05 A | 2014-09-11 A | 100% | 2014-03-05 | 2014-09-12 | 138d? |  | C4; C3 | 3896h | 3896h | ICEH248 | 32 | NSN | Jan.Kall@nsn.com | Rel-12 | 63 | Kimmo | ICEH248 |  |
| 4873 | 1676.1 | CT4 part of ICE impacts on IMS H.248 profiles (Stage 2/3) | 138d? | 2014-03-05 A | 2014-09-11 A | 100% | 2014-03-05 | 2014-09-12 | 138d? | finish no earlier than 2014-09-12 | C4 | 1104h | 1104h | ICEH248 | 32 | NSN | Jan.Kall@nsn.com | Rel-12 | 63 | Kimmo |  |  |
| 4874 | 1676.2 | CT3 part of ICE impacts on IMS H.248 profiles (Stage 2) | 73d? | 2014-03-05 A | 2014-06-13 A | 100% | 2014-03-05 | 2014-06-13 | 73d? | finish no earlier than 2014-06-13 | C3 | 584h | 584h | ICEH248 | 32 | NSN | Jan.Kall@nsn.com | Rel-12 | 63 | Adrian |  |  |
| 4875 | 1677 | **Transfer of ETSI business trunking specifications** | 203d? | 2014-03-05 A | 2014-12-09 A | 100% | 2014-03-05 | 2014-09-17 | 141d? |  | C1; S1 | 5976h | 5976h | IMS_Corp2 | 32 | Alcatel-Lucent | keith.drage@alcatel-lucent.com, Youssef Chadli | Rel-12 | 63 | Frederic | IMS_Corp2 |  |
| 4876 | 1677.1 | SA1 part of Transfer of ETSI business trunking specifications | 141d? | 2014-03-05 A | 2014-09-17 A | 100% | 2014-03-05 | 2014-09-17 | 141d? | finish no earlier than 2014-09-17 | S1 | 1128h | 1128h | IMS_Corp2 | 32 | Alcatel-Lucent | betsy.covell@alcatel-lucent.com | Rel-12 | 63 | Alain |  | S1-143300 |
| 4877 | 1677.2 | CT1 part of Transfer of ETSI business trunking specifications | 200d? | 2014-03-05 A | 2014-12-09 A | 100% | 2014-03-05 | 2014-09-12 | 138d? | finish no earlier than 2014-12-09 | C1 | 1600h | 1600h | IMS_Corp2 | 32 | Alcatel-Lucent | keith.drage@alcatel-lucent.com, Youssef Chadli | Rel-12 | 63 | Frederic |  | CP-140619 |
| 4878 | 1678 | **Support of ALT-C attribute** | 200d? | 2014-03-10 A | 2014-12-09 A | 100% | 2014-03-05 | 2014-09-12 | 138d? |  | C4; C1; C3 | 9600h | 9600h | ALTC | 32 | Orange | lionel.morand@orange.com | Rel-12 | 63 | Kimmo | ALTC |  |
| 4879 | 1678.1 | CT4 part of Support of ALT-C attribute | 200d? | 2014-03-10 A | 2014-12-09 A | 100% | 2014-03-05 | 2014-09-12 | 138d? | finish no earlier than 2014-12-09 | C4 | 1600h | 1600h | ALTC | 32 | Orange | lionel.morand@orange.com | Rel-12 | 63 | Kimmo |  | CP-140485 |
| 4880 | 1678.2 | CT1 part of Support of ALT-C attribute | 200d? | 2014-03-10 A | 2014-12-09 A | 100% | 2014-03-05 | 2014-09-12 | 138d? | finish no earlier than 2014-12-09 | C1 | 1600h | 1600h | ALTC | 32 | Orange | lionel.morand@orange.com | Rel-12 | 63 | Frederic |  | CP-140611 |
| 4881 | 1678.3 | CT3 part of Support of ALT-C attribute | 200d? | 2014-03-10 A | 2014-12-09 A | 100% | 2014-03-05 | 2014-06-13 | 73d? | finish no earlier than 2014-12-09 | C3 | 1600h | 1600h | ALTC | 32 | Orange | lionel.morand@orange.com | Rel-12 | 63 | Adrian |  | CP-140563 |
| 4882 | 1679 | **Diameter Overload Control Mechanisms** | 131d? | 2014-06-13 A | 2014-12-09 A | 100% | 2014-06-13 | 2014-12-05 | 126d? |  | C4; IETF | 4144h | 4144h | DOCME | 33 | Orange | lionel.morand@orange.com | Rel-12 | 64 |  | DOCME |  |
| 4883 | 1679.1 | CT4 part of Diameter Overload Control Mechanisms | 128d? | 2014-06-13 A | 2014-12-09 A | 100% | 2014-06-13 | 2014-09-12 | 66d? | finish no earlier than 2014-12-09 | C4 | 1024h | 1024h | DOCME | 33 | Orange | lionel.morand@orange.com | Rel-12 | 64 |  |  | CP-140486 |
| 4884 | 1679.2 | (IETF) Diameter Overload Control Mechanisms (draft-ietf-dime-ovli) | 128d? | 2014-06-13 A | 2014-12-09 A | 100% | 2014-06-13 | 2014-12-05 | 126d? | finish no earlier than 2014-12-09 | C4-IETF | 1024h | 1024h | DOCME | 33 | christer.holmberg@ericsson.com | christer.holmberg@ericsson.com | Rel-12 | 64 |  |  |  |
| 4885 | 1680 | **Impacts of RFC7044 for introduction of the new History-Info header field** | 131d? | 2014-06-13 A | 2014-12-09 A | 100% | 2014-06-13 | 2014-09-12 | 66d? |  | C1; C3 | 3648h | 3648h | HISTORY_CT | 33 | Deutsche Telekom | Roland Jesske (r.jesske@telekom.de) | Rel-12 | 64 |  | HISTORY_CT |  |
| 4886 | 1680.1 | CT1 part of Impacts of RFC7044 for introduction of the new History-Info header field | 128d? | 2014-06-13 A | 2014-12-09 A | 100% | 2014-06-13 | 2014-09-12 | 66d? | finish no earlier than 2014-12-09 | C1 | 1024h | 1024h | HISTORY_CT | 33 | Deutsche Telekom | Roland Jesske (r.jesske@telekom.de) | Rel-12 | 64 |  |  | CP-140609 |
| 4887 | 1680.2 | CT3 part of Impacts of RFC7044 for introduction of the new History-Info header field | 66d? | 2014-06-13 A | 2014-09-11 A | 100% | 2014-06-13 | 2014-09-12 | 66d? | finish no earlier than 2014-09-12 | C3 | 528h | 528h | HISTORY_CT | 33 | Deutsche Telekom | Roland Jesske (r.jesske@telekom.de) | Rel-12 | 64 |  |  |  |

Notes:
- 4862: Stage 3. Review the references related to RFC 3265 in the 3GPP IMS specifications and determine the impact of the RFC 6665 changes / Impacted TSs and TRs: Stage 3
- 4863: CP#65 completion 09/14=>12/14. Exception in CP-140620. 3/3/15: 100% cpltd. / Impacted TSs and TRs: 23.218; 24.141; 24.147; 24.229; 24.237; 24.292; 24.337; 24.341; 24.604; 24.606; 24.623; 24.628; 24.629; 24.642
- 4864: CP#62 completed / Impacted TSs and TRs: 29.163; 29.165
- 4865: Added as per CT chair indications on 12th March 2015, no WID, no end date; 9/4/21: RFC 7647 added; / Impacted TSs and TRs: draft-ietf-sipcore-refer-clarification; RFC 7647
- 4866: Added as per CT chair indications on 12th March 2015, no WID, no end date¦14/09/15: 50%->100; 9/4/21: RFC 7614 added; / Impacted TSs and TRs: draft-ietf-sipcore-refer-explicit-subscription; RFC 7614
- 4867: Added as per CT chair indications on 12th March 2015, no WID, no end date¦14/09/15: 50%->100 / Impacted TSs and TRs: draft-roach-sipcore-6665-clarification
- 4868: Handling of premium rate numbers remained OPEN in Rel-11 (shifted to Rel-12). CP-130384 LS_out sent to SA1 / GSMA informing this TSG CP#60 decision / Impacted TSs and TRs: Stage 3
- 4869: CP#64 completed / Impacted TSs and TRs: 24.229; 24.315
- 4870: CP#65 completed / Impacted TSs and TRs: 29.165
- 4871: CP#65 completion 09/14=>12/14. Exception in CP-140617.Dec.14: 80->85%. 3/3/15: 100% cpltd. / Impacted TSs and TRs: 24.008; 24.301
- 4872: Add optional ICE support as defined in Rel-8 TS (23.228, 24.229) to Iq, Ix, Mn, Mp, Mc interfaces. SA2 Rel-12 TS 23.228 requires support for ICE in eP-CSCF, eIMS-AGW for WebRTC / Impacted TSs and TRs: Stage 2/3
- 4873: CP#65 completed / Impacted TSs and TRs: 23.333; 23.334; 29.232; 29.238; 29.332; 29.333; 29.334
- 4874: CP#64 completed / Impacted TSs and TRs: 29.162; 29.163; 29.292
- 4875: Rel-12 enhancements to business trunking (BusTI). ETSI E2NA(14)000019 asked 3GPP to take responsibility of business communications over IMS: TS 181 019, TS 182 023, TS 182 024, TS 182 025, TR 183 060
- 4876: SP#65 completed. TS 22.519v200 for Approval / Impacted TSs and TRs: New 22.519 (ETSI 181 019)
- 4877: CP#65 TS 24.525v200 for Approval. TR 24.969v100 for Information. Completion 09/14=>12/14. Exception in CP-140619. Dec.14: 90->100 / Impacted TSs and TRs: New TSs [24.523 (182 023); 24.524 (182 024); 24.525 (182 025)]; New 24.969 (183 069)
- 4878: SA2 TS 23.228 requires UEs supporting IPv4, IPv6 or both IPv4 and IPv6 IP address formats shall be supported by IMS. Specify procedures to support altc SDP attribute within IMS for terminating communications destined to an enterprise network.
- 4879: CP#65 completion 09/14=>12/14. Exception in CP-140485. Dec.14: 0->100 / Impacted TSs and TRs: 23.334; 29.238; 29.334
- 4880: CP#65 completion 09/14=>12/14. Exception in CP-140611. Dec.14: 0->100 / Impacted TSs and TRs: 24.229
- 4881: CP#65 completion 09/14=>12/14. Exception in CP-140563. Dec.14: 0->100 / Impacted TSs and TRs: 29.162
- 4882: Triggered by TR 29.809 Study on Diameter overload control mechanism (FS_DOCME)
- 4883: CP#65 completion 09/14=>12/14. Exception in CP-140486. Dec.14: 70->100 / Impacted TSs and TRs: 29.228; 29.229; 29.272; 29.273; 29.328; 29.329; 29.336; 29.337; 29.344; 29.345
- 4884: Mar15: In WGLC¦7/3/16: 50%->100; 9/4/21: RFC 7683 added; / Impacted TSs and TRs: draft-ietf-dime-ovli; RFC 7683
- 4885: IETF updated RFC4244 for History-Info header field to RFC7044. IETF introduced new features which could be useful for 3GPP use cases.
- 4886: CP#65 completion 09/14=>12/14. Exception in CP-140609. Dec.14: 85->100 / Impacted TSs and TRs: 24.229; 24.259; 24.604
- 4887: CP#65 completed / Impacted TSs and TRs: 29.163; 29.165; 29.292

| ID | WBS | Task | Duration | Start | Finish | Complete | Remaining | Baseline start | Baseline finish | Baseline duration | Total slack | Constraint | Resources | Work | Actual work | Acronym | PCG approved | WI rapporteur name | Release | TSG approved | Acronym_3GU_Export | Status Report | MCC resp |
| --- | --- | --- | --- | --- | --- | --- | --- | --- | --- | --- | --- | --- | --- | --- | --- | --- | --- | --- | --- | --- | --- | --- | --- |
| 4888 | 1681 | **Indication of NNI Routeing scenarios in SIP requests** | 131d? | 2014-06-13 A | 2014-12-09 A | 100% |  | 2014-06-13 | 2014-12-05 | 126d? |  |  | C1; C3; IETF | 4408h | 4408h | NNI_RS | 33 | Ericsson | Rel-12 | 64 | NNI_RS |  |  |
| 4889 | 1681.1 | CT1 part of Indication of NNI Routeing scenarios in SIP requests | 128d? | 2014-06-13 A | 2014-12-09 A | 100% |  | 2014-06-13 | 2014-09-12 | 66d? |  | finish no earlier than 2014-12-09 | C1 | 1024h | 1024h | NNI_RS | 33 | Ericsson | Rel-12 | 64 |  | CP-140613 |  |
| 4890 | 1681.2 | (IETF) CT1 part of Indication of NNI Routeing scenarios in SIP requests (draft-holmberg-dispatch-iotl) | 95d? | 2014-06-13 A | 2014-12-09 A | 100% |  | 2014-06-13 | 2014-12-05 | 93d? |  | finish no earlier than 2014-12-09 | C1-IETF | 760h | 760h | NNI_RS | 33 | christer.holmberg@ericsson.com | Rel-12 | 64 |  |  |  |
| 4891 | 1681.3 | CT3 part of Indication of NNI Routeing scenarios in SIP requests | 66d? | 2014-06-13 A | 2014-09-11 A | 100% |  | 2014-06-13 | 2014-09-12 | 66d? |  | finish no earlier than 2014-09-12 | C3 | 528h | 528h | NNI_RS | 33 | Ericsson | Rel-12 | 64 |  |  |  |
| 4892 | 1682 | Unstructured Supplementary Service Data (USSD) method selection (Stage 3) | 3d? | 2014-06-11 A | 2014-06-13 A | 100% |  | 2014-06-11 | 2014-06-13 | 3d? |  | finish no earlier than 2014-06-13 | C1 | 24h | 24h | USSD_MS | 33 | Ericsson | Rel-12 | 64 | USSD_MS |  |  |
| 4893 | 1683 | Representational State Transfer (REST) reference point between Application Function (AF) and Protocol Converter (PC) | 128d? | 2014-06-13 A | 2014-12-09 A | 100% |  | 2014-06-13 | 2014-09-12 | 66d? |  | finish no earlier than 2014-12-09 | C3 | 1024h | 1024h | REST_AF_PC | 33 | Alcatel-Lucent | Rel-12 | 64 | REST_AF_PC | CP-140561 |  |
| 4894 | 1684 | **Overload Control for PCC based Diameter applications** | 131d? | 2014-06-13 A | 2014-12-09 A | 100% |  | 2014-06-13 | 2014-12-05 | 126d? |  |  | C3; IETF | 3648h | 3648h | DOCME-PCC | 33 | Huawei | Rel-12 | 64 | DOCME-PCC |  |  |
| 4895 | 1684.1 | CT3 part of Overload Control for PCC based Diameter applications | 66d? | 2014-06-13 A | 2014-09-11 A | 100% |  | 2014-06-13 | 2014-09-12 | 66d? |  | finish no earlier than 2014-09-12 | C3 | 528h | 528h | DOCME-PCC | 33 | Huawei | Rel-12 | 64 |  |  |  |
| 4896 | 1684.2 | (IETF) Overload Control for PCC based Diameter applications | 128d? | 2014-06-13 A | 2014-12-09 A | 100% |  | 2014-06-13 | 2014-12-05 | 126d? |  | finish no earlier than 2014-12-09 | C3-IETF | 1024h | 1024h | DOCME-PCC | 33 | christer.holmberg@ericsson.com | Rel-12 | 64 |  |  |  |
| 4897 | 1685 | Network Initiated USSD Simulation Services in IMS | 63d? | 2014-09-12 A | 2014-12-09 A | 100% |  |  |  |  |  | finish no earlier than 2014-12-09 | C1 | 504h | 504h | USSI-NET | 33 | AT&T | Rel-12 | 65 | USSI-NET | CP-140610 |  |
| 4898 | 1686 | **Introduction of ER-GSM band for GSM-R** | 651d? | 2011-09-16 A | 2014-02-28 A | 100% |  | 2011-09-16 | 2014-02-28 | 651d? |  |  | G1; C1; G3new | 26496h | 26496h | RT_ERGSM | 27 | Kapsch Carriercom, Sierra Wireless | Rel-12 | 51 | RT_ERGSM |  | Paolo |
| 4899 | 1686.1 | GERAN1 part of Introduction of ER-GSM band for GSM-R | 647d? | 2011-09-16 A | 2014-02-28 A | 100% |  | 2011-09-16 | 2014-02-28 | 647d? |  | finish no earlier than 2014-02-28 | G1 | 5168h | 5168h | RT_ERGSM | 27 | Kapsch Carriercom, Sierra Wireless | Rel-12 | 51 |  |  | Paolo |
| 4900 | 1686.2 | Test part: Introduction of ER-GSM band for GSM-R | 131d? | 2013-09-02 A | 2014-02-28 A | 100% |  | 2013-09-02 | 2014-02-28 | 131d? |  | finish no earlier than 2014-02-28 | G3new | 1048h | 1048h | RT_ERGSM | 31 | Kapsch Carriercom, Sierra Wireless | Rel-12 | 59 |  |  | Ingbert |
| 4901 | 1686.3 | CT1 part of Introduction of ER-GSM band for GSM-R | 582d? | 2011-09-28 A | 2013-12-06 A | 100% |  | 2011-09-28 | 2013-12-06 | 582d? |  | finish no earlier than 2013-12-06 | C1 | 4656h | 4656h | RT_ERGSM | 27 | Kapsch Carriercom, Sierra Wireless | Rel-12 | 53 |  |  | Frederic |
| 4902 | 1687 | **Downlink Multi Carrier GERAN** | 666d? | 2012-09-10 A | 2015-03-13 | 91% | 61.92d? | 2012-09-10 | 2014-09-12 | 533d? | 2867d |  | G2; G1; C1; G3new | 34536h | 31495.3h | DMCG | 29 | Ericsson | Rel-12 | 55 | DMCG |  | Gert |
| 4903 | 1687.1 | Core part: Downlink Multi Carrier GERAN | 229d? | 2013-07-22 A | 2014-05-30 A | 100% |  | 2013-07-22 | 2014-05-30 | 229d? |  | finish no earlier than 2014-05-30 | G2; G1 | 3664h | 3664h | DMCG | 29 | Ericsson | Rel-12 | 55 |  |  | Gert |
| 4904 | 1687.2 | CT part: Downlink Multi Carrier GERAN | 533d? | 2012-09-10 A | 2014-09-11 A | 100% |  | 2012-09-10 | 2014-09-12 | 533d? |  | finish no earlier than 2014-09-12 | C1 | 4264h | 4264h | DMCG | 29 | Ericsson | Rel-12 | 55 |  |  | Frederic |
| 4905 | 1687.3 | Test part: Downlink Multi Carrier GERAN | 662d? | 2012-09-10 A | 2015-03-13 | 80% | 132.4d? | 2012-09-10 | 2014-08-29 | 522d? | 2867d | finish no earlier than 2015-03-13 | G3new | 5296h | 4236.8h | DMCG-MStest | 29 | ST-Ericsson | Rel-12 | 55 | DMCG-MStest |  | Ingbert |
| 4906 | 1688 | **Mobile Station Receive Diversity (MSRD) for Voice Services over Adaptive Multi-user channels on One Slot (VAMOS)** | 459d? | 2013-03-01 A | 2014-11-21 A | 100% |  | 2013-03-01 | 2014-08-29 | 396d? |  |  | G1; G2; C1; G3new | 24064h | 24064h | MSRD_VAMOS | 30 | Nokia Networks, Microsoft | Rel-12 | 57 | MSRD_VAMOS | GP-140579 | Paolo |
| 4907 | 1688.1 | CT1 introduction of MS capability support for MS supporting MSRD for VAMOS | 205d? | 2013-03-01 A | 2013-12-06 A | 100% |  | 2013-03-01 | 2013-12-06 | 205d? |  | finish no earlier than 2013-12-06 | C1 | 1640h | 1640h | MSRD_VAMOS | 30 | Nokia Networks, Microsoft | Rel-12 | 57 |  |  | Frederic |
| 4908 | 1688.2 | MSRD for VAMOS - Performance Requirements | 257.5d? | 2013-11-28 A | 2014-11-21 A | 100% |  | 2013-11-28 | 2014-08-29 | 197.5d? |  | finish no earlier than 2014-11-21 | G1; G2 | 4120h | 4120h | MSRD_VAMOS-PerfReq | 30 | Nokia Networks, Microsoft | Rel-12 | 57 | MSRD_VAMOS-PerfReq | GP-140579 | Paolo |
| 4909 | 1688.3 | MSRD for VAMOS - MS Conformance Test | 453d? | 2013-03-06 A | 2014-11-21 A | 100% |  | 2013-03-06 | 2014-08-29 | 393d? |  | finish no earlier than 2014-11-21 | G3new | 3616h | 3616h | MSRD_VAMOS-Test | 30 | Nokia Networks, Microsoft | Rel-12 | 57 | MSRD_VAMOS-Test | GP-140579 | Ingbert |
| 4910 | 1689 | **New Training Sequence Codes (TSC) for GERAN** | 277d? | 2013-11-22 A | 2014-12-09 | 93% | 18.18d? | 2013-11-22 | 2014-08-29 | 202d? | 2935d |  | G1; G2; C1 | 11184h | 10449.7h | NewToN | 32 | Ericsson | Rel-12 | 60 | NewToN | GP-140542 | Paolo |
| 4911 | 1689.1 | GERAN1 part of New Training Sequence Codes (TSC) for GERAN | 261d? | 2013-11-22 A | 2014-11-21 A | 100% |  | 2013-11-22 | 2014-08-29 | 201d? |  | finish no earlier than 2014-11-21 | G1 | 2088h | 2088h | NewToN | 32 | Ericsson | Rel-12 | 60 |  | GP-140542 | Paolo |
| 4912 | 1689.2 | GERAN2 part of New Training Sequence Codes (TSC) for GERAN | 261d? | 2013-11-22 A | 2014-11-19 | 80% | 52.2d? | 2013-11-22 | 2014-08-29 | 201d? | 2949d | finish no earlier than 2014-11-21 | G2 | 2088h | 1670.4h | NewToN | 32 | Ericsson | Rel-12 | 60 |  | GP-140542 | Gert |
| 4913 | 1689.3 | CT1 part of New Training Sequence Codes (TSC) for GERAN (Stage 3) | 273d? | 2013-11-22 A | 2014-12-09 A | 100% |  | 2013-11-22 | 2014-08-29 | 201d? |  | finish no earlier than 2014-12-09 | C1 | 2184h | 2184h | NewToN | 32 | Ericsson | Rel-12 | 60 |  | CP-140604 | Frederic |

Notes:
- 4888: Triggered by TR 24.802 Study on Indication of Network to Network Interface (NNI) Routeing scenarios in SIP requests UID_580025 / WI rapporteur e-mail: Jan.Holm@ericsson.com
- 4889: CP#65 completion 09/14=>12/14. Exception in CP-140613. Dec.14: 95->100 / Impacted TSs and TRs: 24.229 / WI rapporteur e-mail: Jan.Holm@ericsson.com
- 4890: Publication requested¦7/3/16: 50%->100 / Impacted TSs and TRs: draft-holmberg-dispatch-iotl / WI rapporteur e-mail: christer.holmberg@ericsson.com
- 4891: CP#65 completed / Impacted TSs and TRs: 29.079; 29.165 / WI rapporteur e-mail: Jan.Holm@ericsson.com
- 4892: CP#64 approved WID & completed. Related to R11 USSD simulation service in IMS (delivery of UE originating USSD request using IMS, I.e. introduce 2nd method for delivery of UE originating USSD request to network (additional to USSD using CS domain) / Impacted TSs and TRs: 24.173; 24.390; New 24.391 / WI rapporteur e-mail: ivo.sedlacek@ericsson.com
- 4893: CP#65 completion 09/14=>12/14. TS 29.201v200 for Approval. Exception in CP-140561. Dec.14: 80->100 / Impacted TSs and TRs: 29.213; 29.214; new 29.201 / WI rapporteur e-mail: horst.brinkmann@alcatel-lucent.com
- 4894: Triggered by TR 29.809 Study on Diameter overload control mechanism (FS_DOCME) / WI rapporteur e-mail: Xia Haitao (xiahaitao@huawei.com)
- 4895: CP#65 completed / Impacted TSs and TRs: 29.212; 29.213; 29.214 / WI rapporteur e-mail: Xia Haitao (xiahaitao@huawei.com)
- 4896: work in progress¦7/3/16: 50%->100 / Impacted TSs and TRs: draft-ietf-dime-ovli / WI rapporteur e-mail: christer.holmberg@ericsson.com
- 4897: CP#65 exception in CP-140610. Dec.14: 75->100 / Impacted TSs and TRs: 24.390 / WI rapporteur e-mail: Martin Dolly (md3135@att.com)
- 4898: Use of band 870-876/915-921 MHz for land mobile service on national possibilities/market demand - as per ECC/DEC/(04)06. Introduction of ERGSM band, Performance requirements and Deployment scenarios. / Impacted TSs and TRs: GERAN / WI rapporteur e-mail: thomas.chatelet@kapsch.net, Rémi Lascoux (rlascoux@sierrawireless.com)
- 4899: GP#61 completed. GP#51 approved WID / Impacted TSs and TRs: 45.001; 45.005; 45.008; 45.050 / WI rapporteur e-mail: thomas.chatelet@kapsch.net, Rémi Lascoux (rlascoux@sierrawireless.com)
- 4900: GP#61 completed / Impacted TSs and TRs: 51.010; 51.021 / WI rapporteur e-mail: thomas.chatelet@kapsch.net, Rémi Lascoux (rlascoux@sierrawireless.com)
- 4901: CP#62 completed. Added ERGSM capability indication (24.008 CR#2469R1) / Impacted TSs and TRs: 24.008 / WI rapporteur e-mail: thomas.chatelet@kapsch.net, Rémi Lascoux (rlascoux@sierrawireless.com)
- 4902: Linked to Rel-7 Downlink Dual Carrier UID_50579 (Previous work on multiple carriers on the downlink was limited to two). Ref: TR 45.912 Feasibility study for evolved GERAN, TS 43.064 GPRS Stage 2 / Impacted TSs and TRs: GERAN / WI rapporteur e-mail: paul.schliwa-bertling@ericsson.com
- 4903: GP#62 completed. GP#55 approved WID / Impacted TSs and TRs: 43.064; 44.004; 44.018; 44.060; 45.002; 45.003; 45.005; 45.008; 48.018 / WI rapporteur e-mail: paul.schliwa-bertling@ericsson.com
- 4904: CP#65 completed / Impacted TSs and TRs: 24.008 / WI rapporteur e-mail: paul.schliwa-bertling@ericsson.com
- 4905: GP#63 completion 08/14=>11/14. Dec.14: 35->80%, CD:11/14->03/15 / Impacted TSs and TRs: 51.010-1; 51.010-2 / WI rapporteur e-mail: hakan.e.grunditz@stericsson.com
- 4906: GP#63 completion 08/14=>11/14. Exception in GP-140579. Linked to Rel-7 Mobile Station Receive Diversity (DARP Phase II) UID_50569, Rel-9 Voice Services over Adaptive Multiuser channels on One Slot (VAMOS) UID_420002 / Impacted TSs and TRs: GERAN / WI rapporteur e-mail: Khairul Hasan (Nokia Networks), Markku Tarkiainen (Nokia=>Microsoft)
- 4907: CP#62 completed / Impacted TSs and TRs: 24.008 / WI rapporteur e-mail: Khairul Hasan (Nokia Networks), Markku Tarkiainen (Nokia=>Microsoft)
- 4908: GP#63 completion 08/14=>11/14. Exception in GP-140579. Dec.14: 95->100 / Impacted TSs and TRs: 44.018; 45.001; 45.002; 45.005; 45.008; 45.009 / WI rapporteur e-mail: Khairul Hasan (Nokia Networks), Markku Tarkiainen (Nokia=>Microsoft)
- 4909: GP#63 completion 08/14=>11/14. Exception in GP-140579. Dec.14: 85->100 / Impacted TSs and TRs: 51.010-1; 51.010-2 / WI rapporteur e-mail: Khairul Hasan (Nokia Networks), Markku Tarkiainen (Nokia=>Microsoft)
- 4910: GP#63 completion 08/14=>11/14. Exception in GP-140542. GP#60 approved WID. Triggered by GP-131041, GP#40 GP-081949 (WID VAMOS). Linked to Rel-9 VAMOS (Previous work where new TSCs were defined for GMSK modulation) UID_420002 / Impacted TSs and TRs: GERAN / WI rapporteur e-mail: Mårten Sundberg
- 4911: GP#63 completion 08/14=>11/14. Exception in GP-140542. Dec.14: 80->100% / Impacted TSs and TRs: 45.001; 45.002; 45.008; 45.009; 45.050 / WI rapporteur e-mail: Mårten Sundberg
- 4912: GP#63 completion 08/14=>11/14. Exception in GP-140542. / Impacted TSs and TRs: 44.018; 44.060 / WI rapporteur e-mail: Mårten Sundberg
- 4913: CP#65 completion 09/14=>12/14. CP#65 exception in CP-140604. 3/3/15: 100% cpltd. / Impacted TSs and TRs: 24.008 / WI rapporteur e-mail: Mårten Sundberg

| ID | WBS | Task | Duration | Start | Finish | Complete | Remaining | Baseline start | Baseline finish | Baseline duration | Total slack | Constraint | Resources | Work | Actual work | Acronym | PCG approved | WI rapporteur name | Release | TSG approved | MCC resp | Acronym_3GU_Export | Status Report | Special Focus Doc | PCG stopped | TSG stopped |
| --- | --- | --- | --- | --- | --- | --- | --- | --- | --- | --- | --- | --- | --- | --- | --- | --- | --- | --- | --- | --- | --- | --- | --- | --- | --- | --- |
| 4914 | 1690 | **Verification of radiated multi-antenna reception performance of UEs in LTE/UMTS** | 469d? | 2012-03-05 A | 2013-12-06 A | 100% |  | 2012-03-05 | 2013-12-06 | 469d? |  |  | R4 | 7464h | 7464h | HSPA_LTE_measRP_MIMO | 28 | Vodafone | Rel-12 | 55 | Issam | HSPA_LTE_measRP_MIMO |  |  |  |  |
| 4915 | 1690.1 | Perf. Part: Verification of radiated multi-antenna reception performance of UEs in LTE/UMTS | 464d? | 2012-03-05 A | 2013-12-06 A | 100% |  | 2012-03-05 | 2013-12-06 | 464d? |  | finish no earlier than 2013-12-06 | R4 | 3712h | 3712h | HSPA_LTE_measRP_MIMO-Perf | 28 | Vodafone | Rel-12 | 55 | Issam | HSPA_LTE_measRP_MIMO-Perf | RP-131507 |  |  |  |
| 4916 | 1691 | **Further enhancements to H(e)NB mobility - Part 3 (Stage 2/3)** | 330d? | 2012-09-12 A | 2013-12-06 A | 100% |  | 2012-09-12 | 2013-12-06 | 330d? |  |  | R3; R2 | 10560h | 10560h | EHNB_enh3 | 29 | Alcatel-Lucent | Rel-12 | 57 | Juha | EHNB_enh3 |  | HNB |  |  |
| 4917 | 1691.1 | Core part: Further enhancements to H(e)NB mobility - Part 3 | 330d? | 2012-09-12 A | 2013-12-06 A | 100% |  | 2012-09-12 | 2013-12-06 | 330d? |  | finish no earlier than 2013-12-06 | R3; R2 | 5280h | 5280h | EHNB_enh3-Core | 29 | Alcatel-Lucent | Rel-12 | 57 | Juha | EHNB_enh3-Core | RP-131508 | HNB |  |  |
| 4918 | 1692 | **Support for BeiDou Navigation Satellite System (BDS) for UTRA and LTE** | 604d? | 2013-03-04 A | 2015-06-15 A | 100% |  | 2013-03-04 | 2015-06-12 | 600d? |  |  | R2; R3; R4; R5 | 31680h | 31680h | LCS_BDS | 30 | CATR | Rel-12 | 59 | Yong-Jun | LCS_BDS |  |  |  |  |
| 4919 | 1692.1 | Core part: Support for BeiDou Navigation Satellite System (BDS) for UTRA | 204d? | 2013-06-02 A | 2014-03-06 A | 100% |  | 2013-06-02 | 2014-03-06 | 204d? |  | finish no earlier than 2014-03-06 | R2; R3 | 3264h | 3264h | LCS_BDS-UTRA-Core | 30 | ZTE | Rel-12 | 59 | Yong-Jun | LCS_BDS-UTRA-Core | RP-131500 |  |  |  |
| 4920 | 1692.2 | Perf. part: Support for BeiDou Navigation Satellite System (BDS) for UTRA | 336d? | 2013-03-07 A | 2014-06-13 A | 100% |  | 2013-03-07 | 2014-06-13 | 336d? |  | finish no earlier than 2014-06-13 | R4 | 2688h | 2688h | LCS_BDS-UTRA-Perf | 30 | ZTE | Rel-12 | 59 | Issam | LCS_BDS-UTRA-Perf | RP-140714 |  |  |  |
| 4921 | 1692.3 | Core part: Support for BeiDou Navigation Satellite System (BDS) for LTE | 202d? | 2013-03-04 A | 2013-12-06 A | 100% |  | 2013-03-04 | 2013-12-06 | 202d? |  | finish no earlier than 2013-12-06 | R2 | 1616h | 1616h | LCS_BDS-LTE-Core | 30 | CATR | Rel-12 | 59 | Yong-Jun | LCS_BDS-LTE-Core | RP-131525 |  |  |  |
| 4922 | 1692.4 | Perf. part: Support for BeiDou Navigation Satellite System (BDS) for LTE | 336d? | 2013-03-07 A | 2014-06-13 A | 100% |  | 2013-03-07 | 2014-06-13 | 336d? |  | finish no earlier than 2014-06-13 | R4 | 2688h | 2688h | LCS_BDS-LTE-Perf | 30 | ZTE | Rel-12 | 59 | Issam | LCS_BDS-LTE-Perf | RP-140713 |  |  |  |
| 4923 | 1692.5 | Test part: BeiDou Navigation Satellite System (BDS) Positioning Support for LTE and UMTS | 262d? | 2014-06-15 A | 2015-06-15 A | 100% |  | 2014-06-13 | 2015-06-12 | 261d? |  | finish no earlier than 2015-06-15 | R5 | 2096h | 2096h | LCS_BDS-UEConTest | 33 | CATT | Rel-12 | 64 |  | LCS_BDS-UEConTest | RP-150656 |  |  |  |
| 4924 | 1693 | **Support for BeiDou Navigation Satellite System (BDS) for LCS in GERAN** | 345d? | 2013-11-22 A | 2015-03-13 | 93% | 25.19d? | 2013-11-22 | 2014-11-21 | 262d? | 2867d |  | G2; G1; G3new | 14213.2h | 5848.39h | LCS_BDS_GERAN | 32 | ZTE | Rel-12 | 60 | Gert | LCS_BDS_GERAN |  |  |  |  |
| 4925 | 1693.1 | GERAN2 part of Support for BeiDou Navigation Satellite System (BDS) for LCS in GERAN | 201d? | 2013-11-22 A | 2014-08-29 A | 100% |  | 2013-11-22 | 2014-08-29 | 201d? |  | finish no earlier than 2014-08-29 | G2 | 1608h | 1608h | LCS_BDS_GERAN | 32 | ZTE | Rel-12 | 60 | Gert |  |  |  |  |  |
| 4926 | 1693.2 | GERAN1 part of Support for BeiDou Navigation Satellite System (BDS) for LCS in GERAN | 201d? | 2013-11-22 A | 2014-08-29 A | 100% |  | 2013-11-22 | 2014-08-29 | 201d? |  | finish no earlier than 2014-08-29 | G1 | 1608h | 1608h | LCS_BDS_GERAN | 32 | ZTE | Rel-12 | 60 | Paolo |  |  |  |  |  |
| 4927 | 1693.3 | Support for BeiDou Navigation Satellite System (BDS) for LCS in GERAN3new | 272d? | 2014-03-01 A | 2015-03-13 | 80% | 54.4d? | 2014-02-28 | 2014-11-21 | 192d? | 2867d | finish no earlier than 2015-03-13 | G3new | 2176h | 1740.8h | LCS_BDS_GERAN-GERAN3new | 32 | CATR | Rel-12 | 61 | Ingbert | LCS_BDS_GERAN-GERAN3new |  |  |  |  |
| 4928 | 1693.4 | Deleted - Test part: Support for BeiDou Navigation Satellite System (BDS) for LCS in GERAN | 71d? | 2013-11-22 A | 2014-02-28 A | 100% |  | 2013-11-22 | 2014-02-28 | 71d? |  | finish no earlier than 2014-08-29 | G3new | 565.19h | 565.19h | LCS_BDS_GERAN-MStest | 32 | ZTE | Rel-12 | 60 | Ingbert | LCS_BDS_GERAN-MStest |  |  | PCG-32 | GP-61 |
| 4929 | 1694 | **Deleted - New Base Station specification structure** | 127d? | 2013-06-18 A | 2013-12-06 A | 100% |  | 2013-06-18 | 2013-12-06 | 127d? |  |  | R4 | 3024h | 3024h | BSspec_struc | 31 | Ericsson | Rel-12 | 60 | Issam | BSspec_struc |  |  | PCG-32 | RP-62 |
| 4930 | 1694.1 | Deleted - Core part: New Base Station specification structure | 126d? | 2013-06-18 A | 2013-12-06 A | 100% |  | 2013-06-18 | 2013-12-06 | 126d? |  | finish no earlier than 2013-12-06 | R4 | 1008h | 1008h | BSspec_struc-Core | 31 | Ericsson | Rel-12 | 60 | Issam | BSspec_struc-Core | RP-131513 |  | PCG-32 | RP-62 |
| 4931 | 1694.2 | Deleted - Perf. part: New Base Station specification structure | 125d? | 2013-06-20 A | 2013-12-06 A | 100% |  | 2013-06-20 | 2013-12-06 | 125d? |  | finish no earlier than 2013-12-06 | R4 | 1000h | 1000h | BSspec_struc-Perf | 31 | Ericsson | Rel-12 | 60 | Issam | BSspec_struc-Perf | RP-131514 |  | PCG-32 | RP-62 |
| 4932 | 1695 | **L-band for Supplemental Downlink in E-UTRA and UTRA** | 659d? | 2013-06-17 A | 2015-12-15 A | 100% |  | 2013-06-17 | 2014-06-13 | 264d? |  |  | R4; R2; R3 | 21600h | 21600h | LTE_UTRA_SDL_BandL | 31 | Orange | Rel-12 | 60 | Issam | LTE_UTRA_SDL_BandL |  |  |  |  |
| 4933 | 1695.1 | Core part: L-band for Supplemental Downlink in E-UTRA and UTRA | 87.33d? | 2014-02-13 A | 2014-06-13 A | 100% |  | 2014-02-13 | 2014-06-13 | 87.33d? |  | finish no earlier than 2014-06-13 | R4; R2; R3 | 2096h | 2096h | LTE_UTRA_SDL_BandL-Core | 31 | Orange | Rel-12 | 60 | Issam | LTE_UTRA_SDL_BandL-Core | RP-140633 |  |  |  |
| 4934 | 1695.2 | Perf. part: L-band for Supplemental Downlink in E-UTRA and UTRA | 264d? | 2013-06-17 A | 2014-06-13 A | 100% |  | 2013-06-17 | 2014-06-13 | 264d? |  | finish no earlier than 2014-06-13 | R4 | 2112h | 2112h | LTE_UTRA_SDL_BandL-Perf | 31 | Orange | Rel-12 | 60 | Issam | LTE_UTRA_SDL_BandL-Perf | RP-140633 |  |  |  |
| 4935 | 1695.3 | UE Conformance Test Aspects - L-band for Supplemental Downlink in E-UTRA and UTRA | 197d? | 2015-03-16 A | 2015-12-15 A | 100% |  |  |  |  |  | finish no earlier than 2015-12-15 | R5 | 1576h | 1576h | LTE_UTRA_SDL_BandL-UEConTest | 34 | Ericsson | Rel-12 | 67 |  |  | RP-151163 |  |  |  |
| 4936 | 1696 | **LTE-HRPD (High Rate Packet Data in 3GPP2) inter-RAT SON** | 263d? | 2013-06-18 A | 2014-06-13 A | 100% |  | 2013-06-18 | 2014-06-13 | 263d? |  |  | R3; S2; C4; G2 | 11096h | 11096h | LTE_HRPD_SON | 31 | China Telecom | Rel-12 | 60 | Juha | LTE_HRPD_SON |  | SON |  |  |
| 4937 | 1696.1 | Stage 2 for LTE-HRPD (High Rate Packet Data in 3GPP2) inter-RAT SON | 67d? | 2013-09-11 A | 2013-12-11 A | 100% |  | 2013-09-11 | 2013-12-11 | 67d? |  | finish no earlier than 2013-09-11 | S2 | 528h | 528h | LTE_HRPD_SON | 31 | Huawei | Rel-12 | 61 | Maurice |  |  |  |  |  |
| 4938 | 1696.2 | Core part: LTE-HRPD (High Rate Packet Data in 3GPP2) inter-RAT SON | 263d? | 2013-06-18 A | 2014-06-13 A | 100% |  | 2013-06-18 | 2014-06-13 | 263d? |  | finish no earlier than 2014-06-13 | R3 | 2088h | 2088h | LTE_HRPD_SON-Core | 31 | China Telecom | Rel-12 | 60 | Juha | LTE_HRPD_SON-Core | RP-140745 |  |  |  |
| 4939 | 1696.3 | CT aspects for LTE-HRPD (High Rate Packet Data in 3GPP2) inter-RAT SON (Stage 3) | 3d? | 2013-09-04 A | 2013-09-06 A | 100% |  | 2013-09-04 | 2013-09-06 | 3d? |  | finish no earlier than 2013-09-06 | C4 | 24h | 24h | LTE_HRPD_SON-CT | 31 | Huawei | Rel-12 | 61 | Kimmo | LTE_HRPD_SON-CT |  |  |  |  |
| 4940 | 1696.4 | GERAN aspects for LTE-HRPD inter-RAT SON, RAN Information Management (RIM) - Stage 3 | 5d? | 2013-08-26 A | 2013-08-30 A | 100% |  | 2013-08-26 | 2013-08-30 | 5d? |  | finish no earlier than 2013-09-06 | G2 | 40h | 40h | LTE_HRPD_SON-RIM | 31 | Alcatel-Lucent | Rel-12 | 59 | Gert | LTE_HRPD_SON-RIM |  |  |  |  |

Notes:
- 4914: RP#59 moved to Rel-12. Triggered by FS_HSPA_LTE_measRP_MIMO_multi-antenna. Core functionality exists since Rel-6 & Rel-7 (MIMO). Adds a very generic test method to test UEs with 2 or more Rx antennas / Impacted TSs and TRs: UTRA; LTE / WI rapporteur e-mail: Luis Anaya
- 4915: RP#62 completed. Rx diversity (defined as Rel-6 HSDPA RAN4 enhanced type 1 req.) & MIMO (defined as Rel-7 HSDPA MIMO for HSPA). Rx diversity & MIMO (defined as part of Rel-8 basic LTE WI) / Impacted TSs and TRs: new 37.977 / WI rapporteur e-mail: luis.anaya@vodafone.com
- 4916: Triggered by FS_EHNB_enh (TR 37.803) / Impacted TSs and TRs: UTRA; LTE / WI rapporteur e-mail: Martin.Warner@alcatel-lucent.com
- 4917: RP#62 completed / Impacted TSs and TRs: 25.304; 25.331; 25.367; 25.467; 25.469; 36.300; 36.331 / WI rapporteur e-mail: Martin.Warner@alcatel-lucent.com
- 4918: BeiDou = Chinese Navigation Satellite System. Location Services (LCS) TS 22.071 Stage 1, TS 23.271 Stage 2 / Impacted TSs and TRs: UTRA; LTE / WI rapporteur e-mail: Ying Du (duying1@catr.cn)
- 4919: RP#62 completed / Impacted TSs and TRs: 25.305; 25.306; 25.331; 25.453; 25.413; 25.423; 25.433 / WI rapporteur e-mail: Huang He (huang.he4@zte.com.cn)
- 4920: RP#64 completed. TS 25.173v100 for 1-step Approval / Impacted TSs and TRs: 25.172 (FDD); new 25.173 (TDD) / WI rapporteur e-mail: Ling Soonleh (soonleh.ling@zte.com.cn)
- 4921: RP#62 completed / Impacted TSs and TRs: 36.305; 36.355 / WI rapporteur e-mail: Ying Du (duying1@catr.cn)
- 4922: RP#64 completed / Impacted TSs and TRs: 36.171 / WI rapporteur e-mail: Ling Soonleh (soonleh.ling@zte.com.cn)
- 4923: ¦Stat Rep: RP-141350->RP-141950 1st Apr 15: Compl:80%->90% 1st Apr 15: Stat Rep: RP-141950->RP-150357 03/07/15: Compl:90%->100% 03/07/15: Stat Rep: RP-150357->RP-150656 / Impacted TSs and TRs: 34.108; 36.508; 37.571-1; 37.571-2; 37.571-3; 37.571-4; 37.571-5 / WI rapporteur e-mail: Chen Xiaiozhong (chenxiaozhong@catt.cn)
- 4924: GP#60 approved WID. Based on the same framework used in Rel-8 Support for Additional Navigation Satellite Systems (ANSS) for LCS UID_38001 / Impacted TSs and TRs: GERAN / WI rapporteur e-mail: Wang Xinhui (wangxinhui@zte.com.cn)
- 4925: GP#63 completed / Impacted TSs and TRs: 44.031; 49.031; 44.071; 48.031 / WI rapporteur e-mail: Wang Xinhui (wangxinhui@zte.com.cn)
- 4926: GP#63 completed / Impacted TSs and TRs: 43.059; 45.005 / WI rapporteur e-mail: Wang Xinhui (wangxinhui@zte.com.cn)
- 4927: Dec.14: 25->80%, CD: 11/14->03/15 / Impacted TSs and TRs: 51010-1; 51.010-2; 51.010-7 / WI rapporteur e-mail: Zhou DaiWei, China Academy of Telecommunication Research, zhoudaiwei@catr.cn
- 4928: GP#61 stopped / Impacted TSs and TRs: 51.010-1 / WI rapporteur e-mail: Wang Xinhui (wangxinhui@zte.com.cn)
- 4929: Triggered by Rel-12 TR 37.810 Study on Base Station specification structure (FS_BSspec_struc) / Impacted TSs and TRs: UTRA; LTE; MSR / WI rapporteur e-mail: johan.skold@ericsson.com
- 4930: RP#62 stopped (at 20% completion) / Impacted TSs and TRs: 25.104; 25.105; 36.104; 37.104; 37.810; New 37.811 (New BS specification structure); New 37.xya (New RF core specification) / WI rapporteur e-mail: johan.skold@ericsson.com
- 4931: RP#62 stopped (at 0% completion) / Impacted TSs and TRs: 25.113; 25.141; 25.142; 36.113; 36.141; 37.113; 37.141; 37.810; New 37.xyz (New RF test specification; New 37.xyw (ew EMC specification) / WI rapporteur e-mail: johan.skold@ericsson.com
- 4932: ECC(12)052 CEPT decision to harmonize 1452-1492 MHz (L-band) for mobile communications Supplemental Downlink (SDL) => standardize L-band and corresponding E-UTRA and UTRA requirements for SDL operation in Region 1 / Impacted TSs and TRs: UTRA; LTE / WI rapporteur e-mail: olfa.benhaddada@orange.com
- 4933: RP#64 completed. RP#65 forgotten TR 37.814 v100 for 1-step Approval / Impacted TSs and TRs: 25.101; 25.104; 25.113; 25.133; 25.307; 25.327; 25.461; 25.466; 34.124; 36.101; 36.104; 36.113; 36.124; 36.133; 36.307; 36.331; 37.104; 37.113; new 37.814 / WI rapporteur e-mail: olfa.benhaddada@orange.com
- 4934: RP#64 completed / Impacted TSs and TRs: 25.133; 25.141; 25.307; 25.327; 36.133; 36.141; 36.307; 37.141 / WI rapporteur e-mail: olfa.benhaddada@orange.com
- 4935: 03/07/15: Compl:0%->85% 03/07/15: CD:Mon 15/06/15->Tue 15/09/15 03/07/15: WID: RP-150134->RP-150835 03/07/15: Stat Rep: ->RP-150830 29/09/15: Compl:85%->90% 29/09/15: CD:Tue 15/09/15->Tue 15/12/15 29/09/15: Stat Rep: RP-150830->RP-151163¦1/1/16
- 4936: Triggered by Rel-12 TR 37.813 (FS_LTE_HRPD_SON). SA2 should verify the architecture solution in TR 37.813 for inter-RAT load balancing between LTE-HRPD. CT4 should specify the RIM extension to support the feature. / Impacted TSs and TRs: UTRA; LTE / WI rapporteur e-mail: Jinlian_wu@189.cn
- 4937: SP#62 completed / Impacted TSs and TRs: 23.402 / WI rapporteur e-mail: Huan Li (ivy.lihuan@huawei.com)
- 4938: RP#64 completed / Impacted TSs and TRs: 36.300; 36.413 / WI rapporteur e-mail: Jinlian_wu@189.cn
- 4939: CP#61 WID approved & Completed / Impacted TSs and TRs: 29.274; 29.276; 29.280 / WI rapporteur e-mail: Xiaoyan SHI (sean.shixiaoyan@huawei.com
- 4940: GP#59 WID approved & Completed / Impacted TSs and TRs: 48.018 / WI rapporteur e-mail: marguerite.woch@alcatel-lucent.com

| ID | WBS | Task | Duration | Start | Finish | Complete | Remaining | Baseline start | Baseline finish | Baseline duration | Total slack | Constraint | Resources | Work | Actual work | Acronym | PCG approved | Impacted TSs and TRs | WI rapporteur name | WI rapporteur e-mail | Release | TSG approved | MCC resp | Acronym_3GU_Export | Status Report | Special Focus Doc | PCG stopped | TSG stopped |
| --- | --- | --- | --- | --- | --- | --- | --- | --- | --- | --- | --- | --- | --- | --- | --- | --- | --- | --- | --- | --- | --- | --- | --- | --- | --- | --- | --- | --- |
| 4941 | 1697 | **Increasing the minimum number of carriers for UE monitoring in UTRA and E-UTRA** | 1245d? | 2013-12-15 A | 2018-09-14 | 99% | 0d? | 2013-12-09 | 2015-03-13 | 331d? | 0d |  | R4; R2 | 20724.4h | 20724.4h | LTE_UTRA_IncMon | 32 | UTRA; LTE | Ericsson | christopher.callender@ericsson.com | Rel-12 | 62 | Issam | LTE_UTRA_IncMon |  |  |  |  |
| 4942 | 1697.1 | Core part: Increasing the minimum number of carriers for UE monitoring in UTRA and E-UTRA | 201d? | 2013-12-15 A | 2014-12-15 A | 100% |  | 2014-01-06 | 2014-09-12 | 133d? |  | finish no earlier than 2014-12-15 | R4; R2 | 1844.4h | 1844.4h | LTE_UTRA_IncMon-Core | 32 | 25.133; 25.331; 36.133 | Ericsson | christopher.callender@ericsson.com | Rel-12 | 62 | Issam | LTE_UTRA_IncMon-Core | RP-141787 |  |  |  |
| 4943 | 1697.2 | Perf. part: Increasing the minimum number of carriers for UE monitoring in UTRA and E-UTRA | 395d? | 2013-12-15 A | 2015-06-15 A | 100% |  | 2013-12-09 | 2015-03-13 | 331d? |  | finish no earlier than 2015-06-15 | R4 | 3160h | 3160h | LTE_UTRA_IncMon-Perf | 32 | 25.133; 36.133 | Ericsson | christopher.callender@ericsson.com | Rel-12 | 62 | Issam | LTE_UTRA_IncMon-Perf | RP-150596 |  |  |  |
| 4944 | 1697.3 | UE Conformance Test Aspects - Increasing the minimum number of carriers for UE monitoring in UTRA and E-UTRA | 720d? | 2015-12-15 A | 2018-09-14 A | 100% |  |  |  |  |  | finish no earlier than 2018-09-15 | R5 | 5760h | 5760h | LTE_UTRA_IncMon-UEConTest | 36 |  | Ericsson |  | Rel-12 | 70 |  |  |  |  |  |  |
| 4945 | 1698 | **WLAN/3GPP Radio Interworking** | 267d? | 2013-12-06 A | 2014-12-09 A | 100% |  | 2013-12-06 | 2014-09-17 | 205d? |  |  | R2; S2; C1; C4 | 11021h | 11021h | UTRA_LTE_WLAN_interw | 32 | UTRA; LTE | Intel | sasha.sirotkin@intel.com | Rel-12 | 62 | Yong-Jun | UTRA_LTE_WLAN_interw |  | WLAN |  |  |
| 4946 | 1698.1 | Core part: WLAN/3GPP Radio Interworking | 202d? | 2013-12-06 A | 2014-09-12 A | 100% |  | 2013-12-06 | 2014-09-12 | 202d? |  | finish no earlier than 2014-09-12 | R2 | 1616h | 1616h | UTRA_LTE_WLAN_interw-Core | 32 | 25.304; 25.306; 25.331; 36.304; 36.306; 36.331 | Intel | sasha.sirotkin@intel.com | Rel-12 | 62 | Yong-Jun | UTRA_LTE_WLAN_interw-Core | RP-141310 | WLAN |  |  |
| 4947 | 1698.2 | SA2 aspects of WLAN/3GPP Radio Interworking | 140d? | 2014-03-07 A | 2014-09-17 A | 100% |  | 2014-03-07 | 2014-09-17 | 139d? |  | finish no earlier than 2014-09-17 | S2 | 1120h | 1120h | UTRA_LTE_WLAN_interw-SA2 | 32 | 23.402; 23.401; 23.060; 23.251 | Alcatel-Lucent | nicolas.drevon@alcatel-lucent.com | Rel-12 | 63 | Maurice | UTRA_LTE_WLAN_interw-SA2 |  | WLAN |  |  |
| 4948 | 1698.3 | **CT aspects of WLAN/3GPP Radio Interworking (Stage 2/3)** | 68d? | 2014-09-09 A | 2014-12-09 A | 100% |  | 2014-06-13 | 2014-09-12 | 66d? |  |  | C1; C4 | 1665.6h | 1665.6h | UTRA_LTE_WLAN_interw-CT | 33 | Stage 2/3 | Alcatel-Lucent | jennifer.liu@alcatel-lucent.com | Rel-12 | 64 |  | UTRA_LTE_WLAN_interw-CT |  | WLAN |  |  |
| 4949 | 1698.3.1 | CT1 part of CT aspects of WLAN/3GPP Radio Interworking (Stage 3) | 68d? | 2014-09-09 A | 2014-12-09 A | 100% |  | 2014-06-13 | 2014-09-12 | 66d? |  | finish no earlier than 2014-12-09 | C1 | 528h | 528h | UTRA_LTE_WLAN_interw-CT | 33 | 24.008; 24.301; 24.302; 24.312 | Alcatel-Lucent | jennifer.liu@alcatel-lucent.com | Rel-12 | 64 |  |  | CP-140720 | WLAN |  |  |
| 4950 | 1698.3.2 | CT4 part of CT aspects of WLAN/3GPP Radio Interworking (Stage 2/3) | 63d? | 2014-09-12 A | 2014-12-09 A | 100% |  |  |  |  |  | finish no earlier than 2014-12-09 | C4 | 504h | 504h | UTRA_LTE_WLAN_interw-CT | 33 | 23.008; 29.002; 29.272; 29.274; 29.305 | Alcatel-Lucent | jennifer.liu@alcatel-lucent.com | Rel-12 | 65 |  |  | CP-140482 | WLAN |  |  |
| 4951 | 1699 | UE Conformance Test Aspects – WLAN/3GPP Radio Interworking | 327d? | 2014-12-15 A | 2016-03-15 A | 100% |  |  |  |  |  | finish no earlier than 2016-03-15 | R5 | 2616h | 2616h | UTRA_LTE_WLAN_interw-UEConTest | 34 |  | Intel | Intel | Rel-12 | 66 |  |  | RP-151264 |  |  |  |
| 4952 | 1700 | **Rel-12 LTE Carrier Aggregation** | 1384d? | 2011-09-19 A | 2016-12-15 A | 100% |  | 2011-09-19 | 2014-12-11 | 855d? |  |  | R4 | 567982h | 567982h | LTE_CA_Rel-12 | 30 | LTE |  |  | Rel-12 | 58 | Issam | LTE_CA_Rel-12 |  | CA |  |  |
| 4953 | 1700.1 | **LTE Advanced inter-band Carrier Aggregation of Band 1 and Band 7** | 792d? | 2011-09-19 A | 2014-09-12 A | 100% |  | 2011-09-19 | 2014-09-12 | 791d? |  |  | R4 | 18896h | 18896h | LTE_CA_B1_B7 | 27 | LTE | Ericsson | christian.bergljung@ericsson.com | Rel-12 | 53 | Issam | LTE_CA_B1_B7 |  | CA |  |  |
| 4954 | 1700.1.1 | Core part:LTE Advanced inter-band Carrier Aggregation of Band 1 and Band 7 | 790d? | 2011-09-19 A | 2014-09-12 A | 100% |  | 2011-09-19 | 2014-09-12 | 790d? |  | finish no earlier than 2014-09-12 | R4 | 6312h | 6312h | LTE_CA_B1_B7-Core | 27 | 36.101; 36.104; new generic 36.851 | Ericsson | christian.bergljung@ericsson.com | Rel-12 | 53 | Issam | LTE_CA_B1_B7-Core | RP-141084 | CA |  |  |
| 4955 | 1700.1.2 | Perf. part:LTE Advanced inter-band Carrier Aggregation of Band 1 and Band 7 | 781d? | 2011-10-03 A | 2014-09-12 A | 100% |  | 2011-09-30 | 2014-09-12 | 781d? |  | finish no earlier than 2014-09-12 | R4 | 6248h | 6248h | LTE_CA_B1_B7-Perf | 27 | 36.141; 36.307 | Ericsson | christian.bergljung@ericsson.com | Rel-12 | 53 | Issam | LTE_CA_B1_B7-Perf | RP-141084 | CA |  |  |
| 4956 | 1700.2 | **LTE Advanced intra-band non-contiguous Carrier Aggregation in Band 25** | 462d? | 2011-09-19 A | 2013-06-14 A | 100% |  | 2011-09-19 | 2013-06-14 | 462d? |  |  | R4 | 11056h | 11056h | LTE_CA_NC_B25 | 27 | LTE | Sprint | George.Cummings@sprint.com | Rel-12 | 53 | Issam | LTE_CA_NC_B25 |  | CA |  |  |
| 4957 | 1700.2.1 | Core part:LTE Advanced intra-band non-contiguous Carrier Aggregation in Band 25 | 459d? | 2011-09-19 A | 2013-06-14 A | 100% |  | 2011-09-19 | 2013-06-14 | 459d? |  | finish no earlier than 2013-06-14 | R4 | 3672h | 3672h | LTE_CA_NC_B25-Core | 27 | 36.101; 36.104; 36.133; new 36.833-2-25 | Sprint | George.Cummings@sprint.com | Rel-12 | 53 | Issam | LTE_CA_NC_B25-Core | RP-130563 | CA |  |  |
| 4958 | 1700.2.2 | Perf. part:LTE Advanced intra-band non-contiguous Carrier Aggregation in Band 25 | 461d? | 2011-09-19 A | 2013-06-14 A | 100% |  | 2011-09-19 | 2013-06-14 | 461d? |  | finish no earlier than 2013-06-14 | R4 | 3688h | 3688h | LTE_CA_NC_B25-Perf | 27 | 36.141; 36.307 | Sprint | George.Cummings@sprint.com | Rel-12 | 53 | Issam | LTE_CA_NC_B25-Perf | RP-130759 | CA |  |  |
| 4959 | 1700.3 | **Deleted -LTE Advanced inter-band Carrier Aggregation of Band 3 and Band 5 with 2UL** | 265d? | 2012-03-05 A | 2013-03-01 A | 100% |  | 2012-03-05 | 2013-03-01 | 265d? |  |  | R4 | 6296h | 6296h | LTE_CA_B3_B5_2UL | 28 | LTE | SK Telecom | Seungpyo Hong | Rel-12 | 55 | Issam | LTE_CA_B3_B5_2UL |  | CA | PCG-30 | RP-59 |
| 4960 | 1700.3.1 | Deleted - Core part:LTE Advanced inter-band Carrier Aggregation of Band 3 and Band 5 with 2UL | 262d? | 2012-03-05 A | 2013-03-01 A | 100% |  | 2012-03-05 | 2013-03-01 | 262d? |  | finish no earlier than 2013-03-01 | R4 | 2096h | 2096h | LTE_CA_B3_B5_2UL-Core | 28 | 36.101; 36.104; 36.133; 36.307; new generic 36.851 | SK Telecom | Seungpyo Hong | Rel-12 | 55 | Issam | LTE_CA_B3_B5_2UL-Core | RP-130098 | CA | PCG-30 | RP-59 |
| 4961 | 1700.3.2 | Deleted - Perf. part:LTE Advanced inter-band Carrier Aggregation of Band 3 and Band 5 with 2UL | 260d? | 2012-03-12 A | 2013-03-01 A | 100% |  | 2012-03-12 | 2013-03-01 | 260d? |  | finish no earlier than 2013-03-01 | R4 | 2080h | 2080h | LTE_CA_B3_B5_2UL-Perf | 28 | 36.133; 36.141 | SK Telecom | Seungpyo Hong | Rel-12 | 55 | Issam | LTE_CA_B3_B5_2UL-Perf | RP-130099 | CA | PCG-30 | RP-59 |
| 4962 | 1700.4 | UE Conformance Test Aspects - Further Rel-12 configurations for LTE Advanced Carrier Aggregation with 2UL | 460d? | 2015-03-16 A | 2016-12-15 A | 100% |  |  |  |  |  | finish no earlier than 2016-12-15 | R5 | 3680h | 3680h | LTE_CA_Rel12_2UL-UEConTest | 34 |  | Ericsson | NA | Rel-12 | 67 |  |  |  |  |  |  |
| 4963 | 1700.5 | **LTE Advanced intra-band non-contiguous Carrier Aggregation in Band 3** | 469d? | 2012-03-05 A | 2013-12-06 A | 100% |  | 2012-03-05 | 2013-12-06 | 469d? |  |  | R4 | 11136h | 11136h | LTE_CA_NC_B3 | 28 | LTE | SK Telecom | haesung.park@sk.com | Rel-12 | 55 | Issam | LTE_CA_NC_B3 |  | CA |  |  |
| 4964 | 1700.5.1 | Core part:LTE Advanced intra-band non-contiguous Carrier Aggregation in Band 3 | 462d? | 2012-03-05 A | 2013-12-06 A | 100% |  | 2012-03-05 | 2013-12-06 | 462d? |  | finish no earlier than 2013-12-06 | R4 | 3696h | 3696h | LTE_CA_NC_B3-Core | 28 | 36.101; 36.104; 36.133; new 36.833-2-03 | SK Telecom | haesung.park@sk.com | Rel-12 | 55 | Issam | LTE_CA_NC_B3-Core | RP-131573 | CA |  |  |
| 4965 | 1700.5.2 | Perf. part:LTE Advanced intra-band non-contiguous Carrier Aggregation in Band 3 | 461d? | 2012-03-15 A | 2013-12-06 A | 100% |  | 2012-03-15 | 2013-12-06 | 461d? |  | finish no earlier than 2013-12-06 | R4 | 3688h | 3688h | LTE_CA_NC_B3-Perf | 28 | 36.101; 36.104; 36.133; 36.141; 36.307 | SK Telecom | haesung.park@sk.com | Rel-12 | 55 | Issam | LTE_CA_NC_B3-Perf | RP-131574 | CA |  |  |

Notes:
- 4941: -
- 4942: ¦CD:Thu 18/12/14->Mon 15/12/14¦WID: RP-141966->RP-142235¦Stat Rep: RP-141600->RP-141787
- 4943: ¦CD:Fri 12/06/15->Mon 15/06/15¦WID: RP-141966->RP-142235¦Stat Rep: RP-141600->RP-141787 1st Apr 15: Compl:5%->40% 1st Apr 15: Stat Rep: RP-141787->RP-150063 03/07/15: Compl:40%->100% 03/07/15: Stat Rep: RP-150063->RP-150596
- 4944: 22/3/16: Compl:0%->4%1/7/16: CD:Thu 15/09/16->Thu 15/12/16¦26/9/16: Com 21/3/17: Compl ¦2 ;; 11/10/20: 35%->100
- 4945: Triggered by Rel-12 TR 37.834 Study on WLAN/3GPP Radio Interworking (FS_UTRA_LTE_WLAN_interw)
- 4946: SP#65 completed
- 4947: SP#65 completed
- 4948: CP#65 revised WID CP-140287=>CP-140623 (added CT4 part)
- 4949: CP#65 completion 09/14=>12/14. Exception in CP-140720. 78%->95%. 12/12: 95->78%. 3/3/15: 100% cpltd.
- 4950: CP#65 revised WID CP-140287=>CP-140623 (added CT4 part). Exception in CP-140482. Dec.14: 50->100
- 4951: Rel13->Rel-12¦Moved at appropriate place 1st Apr 15: Compl:0%->5% 1st Apr 15: Stat Rep: ->RP-150098 03/07/15: Compl:5%->20% 03/07/15: Stat Rep: RP-150098->RP-150929 29/09/15: Compl:20%->60% 29/09/15: WID: RP-141879->RP-151270 29/09/15: Stat Rep: RP-15
- 4952: LTE_CA_Rel-12
- 4953: Inter-band CA 2DL
- 4954: RP#65 completed. Updated WID RP-132042=>RP-141487
- 4955: RP#65 completed
- 4956: Intra-band NC
- 4957: RP#60 completed. TR 36.841 for 1-step Approval
- 4958: RP#60 completed
- 4959: Inter-band 2UL
- 4960: RP#59 stopped (covered by new WI LTE_CA_2UL-A4)
- 4961: RP#59 stopped (covered by new WI LTE_CA_2UL-A4)
- 4962: 03/07/15: Compl:0%->29% 03/07/15: Stat Rep: ->RP-150834 29/09/15: Compl:29%->55% 29/09/15: Stat Rep: RP-150834->RP-151166 1/1/16: Compl:55%->70% 1/1/16: CD:Tue 15/12/15->Tue 15/03/16 1/1/16: WID: RP-1¦
- 4963: Intra-band NC
- 4964: RP#62 completed
- 4965: RP#62 completed

| ID | WBS | Task | Duration | Start | Finish | Complete | Baseline start | Baseline finish | Baseline duration | Constraint | Resources | Work | Actual work | Acronym | PCG approved | Impacted TSs and TRs | WI rapporteur name | WI rapporteur e-mail | Release | TSG approved | MCC resp | PCG stopped | TSG stopped | Special Focus Doc | Acronym_3GU_Export | Status Report |
| --- | --- | --- | --- | --- | --- | --- | --- | --- | --- | --- | --- | --- | --- | --- | --- | --- | --- | --- | --- | --- | --- | --- | --- | --- | --- | --- |
| 4966 | 1700.6 | **Deleted - LTE Advanced intra-band contiguous Carrier Aggregation in Band 1** | 265d? | 2012-06-18 A | 2013-06-14 A | 100% | 2012-06-18 | 2013-06-14 | 265d? |  | R4 | 6328h | 6328h | LTE_CA_C_B1 | 29 | LTE | KDDI | Masaaki Obara (ms-obara@kddi.com) | Rel-12 | 56 | Issam | PCG-31 | RP-60 | CA | LTE_CA_C_B1 |  |
| 4967 | 1700.6.1 | Deleted - Core part: LTE Advanced intra-band contiguous Carrier Aggregation in Band 1 | 265d? | 2012-06-18 A | 2013-06-14 A | 100% | 2012-06-18 | 2013-06-14 | 265d? | finish no earlier than 2013-06-14 | R4 | 2120h | 2120h | LTE_CA_C_B1-Core | 29 | 36.101; 36.104; 36.133; 36.141; 36.307; new 36.835 | KDDI | Masaaki Obara (ms-obara@kddi.com) | Rel-12 | 56 | Issam | PCG-31 | RP-60 | CA | LTE_CA_C_B1-Core | RP-130549 |
| 4968 | 1700.6.2 | Deleted - Perf. part: LTE Advanced intra-band contiguous Carrier Aggregation in Band 1 | 261d? | 2012-06-22 A | 2013-06-14 A | 100% | 2012-06-22 | 2013-06-14 | 261d? | finish no earlier than 2013-06-14 | R4 | 2088h | 2088h | LTE_CA_C_B1-Perf | 29 | 36.101; 36.104; 36.133; 36.141; 36.307 | KDDI | Masaaki Obara (ms-obara@kddi.com) | Rel-12 | 56 | Issam | PCG-31 | RP-60 | CA | LTE_CA_C_B1-Perf | RP-130550 |
| 4969 | 1700.7 | **LTE Advanced intra-band non-contiguous Carrier Aggregation in Band 4** | 327d? | 2012-06-18 A | 2013-09-06 A | 100% | 2012-06-18 | 2013-09-06 | 327d? |  | R4 | 7752h | 7752h | LTE_CA_NC_B4 | 29 | LTE | T-Mobile USA | nelson.ueng@t-mobile.com | Rel-12 | 56 | Issam |  |  | CA | LTE_CA_NC_B4 |  |
| 4970 | 1700.7.1 | Core part:LTE Advanced intra-band non-contiguous Carrier Aggregation in Band 4 | 323d? | 2012-06-18 A | 2013-09-06 A | 100% | 2012-06-18 | 2013-09-06 | 323d? | finish no earlier than 2013-09-06 | R4 | 2568h | 2568h | LTE_CA_NC_B4-Core | 29 | 36.101; 36.104; 36.133; new 36.833-2-04 | T-Mobile USA | nelson.ueng@t-mobile.com | Rel-12 | 56 | Issam |  |  | CA | LTE_CA_NC_B4-Core | RP-131039 |
| 4971 | 1700.7.2 | Perf. part:LTE Advanced intra-band non-contiguous Carrier Aggregation in Band 4 | 323d? | 2012-06-22 A | 2013-09-06 A | 100% | 2012-06-22 | 2013-09-06 | 323d? | finish no earlier than 2013-09-06 | R4 | 2568h | 2568h | LTE_CA_NC_B4-Perf | 29 | 36.101; 36.104; 36.133; 36.141; 36.307 | T-Mobile USA | nelson.ueng@t-mobile.com | Rel-12 | 56 | Issam |  |  | CA | LTE_CA_NC_B4-Perf | RP-131040 |
| 4972 | 1700.8 | **LTE Advanced inter-band Carrier Aggregation of Band 2 and Band 4** | 327d? | 2012-06-18 A | 2013-09-06 A | 100% | 2012-06-18 | 2013-09-06 | 327d? |  | R4 | 7752h | 7752h | LTE_CA_B2_B4 | 29 | LTE | T-Mobile USA | nelson.ueng@t-mobile.com | Rel-12 | 56 | Issam |  |  | CA | LTE_CA_B2_B4 |  |
| 4973 | 1700.8.1 | Core part:LTE Advanced inter-band Carrier Aggregation of Band 2 and Band 4 | 321d? | 2012-06-18 A | 2013-09-06 A | 100% | 2012-06-18 | 2013-09-06 | 321d? | finish no earlier than 2013-09-06 | R4 | 2568h | 2568h | LTE_CA_B2_B4-Core | 29 | 36.101; 36.104; 36.133; new generic 36.851 | T-Mobile USA | nelson.ueng@t-mobile.com | Rel-12 | 56 | Issam |  |  | CA | LTE_CA_B2_B4-Core | RP-131007 |
| 4974 | 1700.8.2 | Perf. part:LTE Advanced inter-band Carrier Aggregation of Band 2 and Band 4 | 321d? | 2012-06-22 A | 2013-09-06 A | 100% | 2012-06-22 | 2013-09-06 | 321d? | finish no earlier than 2013-09-06 | R4 | 2568h | 2568h | LTE_CA_B2_B4-Perf | 29 | 36.101; 36.104; 36.133; 36.141; 36.307 | T-Mobile USA | nelson.ueng@t-mobile.com | Rel-12 | 56 | Issam |  |  | CA | LTE_CA_B2_B4-Perf | RP-131376 |
| 4975 | 1700.9 | **LTE Advanced inter-band Carrier Aggregation of Band 23 and Band 29** | 202d? | 2012-09-12 A | 2013-06-14 A | 100% | 2012-09-12 | 2013-06-14 | 202d? |  | R4 | 4832h | 4832h | LTE_CA_B23_B29 | 29 | LTE | DISH Network | mariam.sorond@dish.com, johny.kim@dish.com | Rel-12 | 57 | Issam |  |  | CA | LTE_CA_B23_B29 |  |
| 4976 | 1700.9.1 | Core part:LTE Advanced inter-band Carrier Aggregation of Band 23 and Band 29 | 201d? | 2012-09-12 A | 2013-06-14 A | 100% | 2012-09-12 | 2013-06-14 | 201d? | finish no earlier than 2013-06-14 | R4 | 1608h | 1608h | LTE_CA_B23_B29-Core | 29 | 36.101; 36.104; 36.133; new generic 36.851 | DISH Network | mariam.sorond@dish.com, johny.kim@dish.com | Rel-12 | 57 | Issam |  |  | CA | LTE_CA_B23_B29-Core | RP-130535 |
| 4977 | 1700.9.2 | Perf. part:LTE Advanced inter-band Carrier Aggregation of Band 23 and Band 29 | 201d? | 2012-09-12 A | 2013-06-14 A | 100% | 2012-09-12 | 2013-06-14 | 201d? | finish no earlier than 2013-06-14 | R4 | 1608h | 1608h | LTE_CA_B23_B29-Perf | 29 | 36.141; 36.307 | DISH Network | mariam.sorond@dish.com, johny.kim@dish.com | Rel-12 | 57 | Issam |  |  | CA | LTE_CA_B23_B29-Perf | RP-130536 |
| 4978 | 1700.10 | **LTE Advanced inter-band Carrier Aggregation of Band 3 and Band 26** | 203d? | 2012-09-11 A | 2013-06-14 A | 100% | 2012-09-11 | 2013-06-14 | 203d? |  | R4 | 4840h | 4840h | LTE_CA_B3_B26 | 29 | LTE | KT | Chungwoo HWANG (cwhwang@kt.com) | Rel-12 | 57 | Issam |  |  | CA | LTE_CA_B3_B26 |  |
| 4979 | 1700.10.1 | Core part:LTE Advanced inter-band Carrier Aggregation of Band 3 and Band 26 | 202d? | 2012-09-11 A | 2013-06-14 A | 100% | 2012-09-11 | 2013-06-14 | 202d? | finish no earlier than 2013-06-14 | R4 | 1608h | 1608h | LTE_CA_B3_B26-Core | 29 | 36.101; 36.104; 36.133; 36.307; new generic 36.851 | KT | Chungwoo HWANG (cwhwang@kt.com) | Rel-12 | 57 | Issam |  |  | CA | LTE_CA_B3_B26-Core | RP-130527 |
| 4980 | 1700.10.2 | Perf. part:LTE Advanced inter-band Carrier Aggregation of Band 3 and Band 26 | 202d? | 2012-09-11 A | 2013-06-14 A | 100% | 2012-09-11 | 2013-06-14 | 202d? | finish no earlier than 2013-06-14 | R4 | 1608h | 1608h | LTE_CA_B3_B26-Perf | 29 | 36.101; 36.104; 36.133; 36.141; 36.307 | KT | Chungwoo HWANG (cwhwang@kt.com) | Rel-12 | 57 | Issam |  |  | CA | LTE_CA_B3_B26-Perf | RP-130528 |
| 4981 | 1700.11 | **LTE Advanced inter-band Carrier Aggregation of Band 3 and Band 19** | 203d? | 2012-09-11 A | 2013-06-14 A | 100% | 2012-09-11 | 2013-06-14 | 203d? |  | R4 | 4840h | 4840h | LTE_CA_B3_B19 | 29 | LTE | NTT DOCOMO | Kei ANDO | Rel-12 | 57 | Issam |  |  | CA | LTE_CA_B3_B19 |  |
| 4982 | 1700.11.1 | Core part:LTE Advanced inter-band Carrier Aggregation of Band 3 and Band 19 | 201d? | 2012-09-11 A | 2013-06-14 A | 100% | 2012-09-11 | 2013-06-14 | 201d? | finish no earlier than 2013-06-14 | R4 | 1608h | 1608h | LTE_CA_B3_B19-Core | 29 | 36.101; 36.104; 36.133; new generic 36.851 | NTT DOCOMO | Kei ANDO | Rel-12 | 57 | Issam |  |  | CA | LTE_CA_B3_B19-Core | RP-130525 |
| 4983 | 1700.11.2 | Perf. part:LTE Advanced inter-band Carrier Aggregation of Band 3 and Band 19 | 201d? | 2012-09-13 A | 2013-06-14 A | 100% | 2012-09-13 | 2013-06-14 | 201d? | finish no earlier than 2013-06-14 | R4 | 1608h | 1608h | LTE_CA_B3_B19-Perf | 29 | 36.141; 36.307 | NTT DOCOMO | Kei ANDO | Rel-12 | 57 | Issam |  |  | CA | LTE_CA_B3_B19-Perf | RP-130526 |
| 4984 | 1700.12 | **Deleted -LTE Advanced inter-band Carrier Aggregation of Band 38 and Band 39** | 66d? | 2012-09-11 A | 2012-12-07 A | 100% | 2012-09-11 | 2012-12-07 | 66d? |  | R4 | 1584h | 1584h | LTE_CA_B38_B39 | 29 | LTE | China Mobile | Pan Qun (panqun@chinamobile.com) | Rel-12 | 57 | Issam | PCG-30 | RP-58 | CA | LTE_CA_B38_B39 |  |
| 4985 | 1700.12.1 | Deleted - Core part:LTE Advanced inter-band Carrier Aggregation of Band 38 and Band 39 | 66d? | 2012-09-11 A | 2012-12-07 A | 100% | 2012-09-11 | 2012-12-07 | 66d? | finish no earlier than 2012-12-07 | R4 | 528h | 528h | LTE_CA_B38_B39-Core | 29 | 36.101; 36.104; 36.307; new generic 36.851 | China Mobile | Pan Qun (panqun@chinamobile.com) | Rel-12 | 57 | Issam | PCG-30 | RP-58 | CA | LTE_CA_B38_B39-Core | RP-121624 |
| 4986 | 1700.12.2 | Deleted - Perf. part:LTE Advanced inter-band Carrier Aggregation of Band 38 and Band 39 | 66d? | 2012-09-11 A | 2012-12-07 A | 100% | 2012-09-11 | 2012-12-07 | 66d? | finish no earlier than 2012-12-07 | R4 | 528h | 528h | LTE_CA_B38_B39-Perf | 29 | 36.133; 36.141 | China Mobile | Pan Qun (panqun@chinamobile.com) | Rel-12 | 57 | Issam | PCG-30 | RP-58 | CA | LTE_CA_B38_B39-Perf | RP-121625 |
| 4987 | 1700.13 | **LTE Advanced intra-band contiguous Carrier Aggregation in Band 3** | 265d? | 2012-09-11 A | 2013-09-06 A | 100% | 2012-09-11 | 2013-09-06 | 265d? |  | R4 | 6312h | 6312h | LTE_CA_C_B3 | 29 | LTE | China Unicom | Fei CUI (cuifei1@chinaunicom.cn) | Rel-12 | 57 | Issam |  |  | CA | LTE_CA_C_B3 |  |
| 4988 | 1700.13.1 | Core part: LTE Advanced intra-band contiguous Carrier Aggregation in Band 3 | 263d? | 2012-09-11 A | 2013-09-06 A | 100% | 2012-09-11 | 2013-09-06 | 263d? | finish no earlier than 2013-09-06 | R4 | 2096h | 2096h | LTE_CA_C_B3-Core | 29 | 36.101; 36.104; 36.133; new 36.833-1-03 | China Unicom | Fei CUI (cuifei1@chinaunicom.cn) | Rel-12 | 57 | Issam |  |  | CA | LTE_CA_C_B3-Core | RP-131029 |
| 4989 | 1700.13.2 | Perf. part: LTE Advanced intra-band contiguous Carrier Aggregation in Band 3 | 263d? | 2012-09-11 A | 2013-09-06 A | 100% | 2012-09-11 | 2013-09-06 | 263d? | finish no earlier than 2013-09-06 | R4 | 2096h | 2096h | LTE_CA_C_B3-Perf | 29 | 36.141; 36.307 | China Unicom | Fei CUI (cuifei1@chinaunicom.cn) | Rel-12 | 57 | Issam |  |  | CA | LTE_CA_C_B3-Perf | RP-131030 |

Notes:
- 4966: Intra-band C
- 4967: RP#60 stopped at 10% completion (rationale in RP-130670)
- 4968: RP#60 stopped at 0% completion
- 4969: Intra-band NC
- 4970: RP#61 completed. Updated WID RP-130842=>RP-131135
- 4971: RP#61 completed. Updated WID RP-130842=>RP-131135
- 4972: Inter-band 1 UL
- 4973: RP#61 completed
- 4974: RP#61 completed
- 4975: Inter-band 1 UL
- 4976: RP#60 completed
- 4977: RP#60 completed
- 4978: Inter-band 1 UL
- 4979: RP#60 completed. Updated WID RP-130199=>RP-130658
- 4980: RP#60 completed. Updated WID RP-130199=>RP-130658
- 4981: Inter-band 1 UL
- 4982: RP#60 completed
- 4983: RP#60 completed
- 4984: Inter-band 1 UL
- 4985: RP#58 stopped at 10% completion following regulatory decisions (see instead new WI LTE_CA_B39_B41)
- 4986: RP#58 stopped at 0% completion following regulatory decisions (see instead new WI LTE_CA_B39_B41)
- 4987: Intra-band NC
- 4988: RP#61 completed. Updated WID RP-130294=>RP-131184 (impacted specs)
- 4989: RP#61 completed

| ID | WBS | Task | Duration | Start | Finish | Complete | Baseline start | Baseline finish | Baseline duration | Constraint | Resources | Work | Actual work | Acronym | PCG approved | Impacted TSs and TRs | WI rapporteur name | WI rapporteur e-mail | Release | TSG approved | MCC resp | Special Focus Doc | Acronym_3GU_Export | Status Report |
| --- | --- | --- | --- | --- | --- | --- | --- | --- | --- | --- | --- | --- | --- | --- | --- | --- | --- | --- | --- | --- | --- | --- | --- | --- |
| 4990 | 1700.14 | **LTE Advanced inter-band Carrier Aggregation of Band 1 and Band 8** | 362.8d? | 2012-02-02 A | 2013-06-14 A | 100% | 2012-02-02 | 2013-06-14 | 362.8d? |  | R4 | 6118.4h | 6118.4h | LTE_CA_B1_B8 | 29 | LTE | Softbank Mobile | Kenichi Kihara | Rel-12 | 57 | Issam | CA | LTE_CA_B1_B8 |  |
| 4991 | 1700.14.1 | Core part:LTE Advanced inter-band Carrier Aggregation of Band 1 and Band 8 | 201d? | 2012-02-02 A | 2013-06-14 A | 100% | 2012-02-02 | 2013-06-14 | 201d? | finish no earlier than 2013-06-14 | R4 | 1608h | 1608h | LTE_CA_B1_B8-Core | 29 | 36.101; 36.104; new generic 36.851 | Softbank Mobile | Kenichi Kihara | Rel-12 | 57 | Issam | CA | LTE_CA_B1_B8-Core | RP-130515 |
| 4992 | 1700.14.2 | Perf. part:LTE Advanced inter-band Carrier Aggregation of Band 1 and Band 8 | 202d? | 2012-09-11 A | 2013-06-14 A | 100% | 2012-09-11 | 2013-06-14 | 202d? | finish no earlier than 2013-06-14 | R4 | 1608h | 1608h | LTE_CA_B1_B8-Perf | 29 | 36.141; 36.307 | Softbank Mobile | Kenichi Kihara | Rel-12 | 57 | Issam | CA | LTE_CA_B1_B8-Perf | RP-130516 |
| 4993 | 1700.15 | **LTE Advanced inter-band Carrier Aggregation of Band 3 and Band 28** | 203d? | 2012-09-11 A | 2013-06-14 A | 100% | 2012-09-11 | 2013-06-14 | 203d? |  | R4 | 4840h | 4840h | LTE_CA_B3_B28 | 29 | LTE | eAccess | FukumotoShiro@eaccess.net | Rel-12 | 57 | Issam | CA | LTE_CA_B3_B28 |  |
| 4994 | 1700.15.1 | Core part:LTE Advanced inter-band Carrier Aggregation of Band 3 and Band 28 | 202d? | 2012-09-11 A | 2013-06-14 A | 100% | 2012-09-11 | 2013-06-14 | 202d? | finish no earlier than 2013-06-14 | R4 | 1608h | 1608h | LTE_CA_B3_B28-Core | 29 | 36.101; 36.104; new generic 36.851 | eAccess | FukumotoShiro@eaccess.net | Rel-12 | 57 | Issam | CA | LTE_CA_B3_B28-Core | RP-130529 |
| 4995 | 1700.15.2 | Perf. part:LTE Advanced inter-band Carrier Aggregation of Band 3 and Band 28 | 201d? | 2012-09-12 A | 2013-06-14 A | 100% | 2012-09-12 | 2013-06-14 | 201d? | finish no earlier than 2013-06-14 | R4 | 1608h | 1608h | LTE_CA_B3_B28-Perf | 29 | 36.141; 36.307 | eAccess | FukumotoShiro@eaccess.net | Rel-12 | 57 | Issam | CA | LTE_CA_B3_B28-Perf | RP-130530 |
| 4996 | 1700.16 | **LTE Advanced inter-band Carrier Aggregation of Band 1 and Band 26** | 200d? | 2012-12-07 A | 2013-09-06 A | 100% | 2012-12-07 | 2013-09-06 | 200d? |  | R4 | 4768h | 4768h | LTE_CA_B1_B26 | 30 | LTE | KDDI | Masaaki Obara (ms-obara@kddi.com) | Rel-12 | 58 | Issam | CA | LTE_CA_B1_B26 |  |
| 4997 | 1700.16.1 | Core part:LTE Advanced inter-band Carrier Aggregation of Band 1 and Band 26 | 200d? | 2012-12-07 A | 2013-09-06 A | 100% | 2012-12-07 | 2013-09-06 | 200d? | finish no earlier than 2013-09-06 | R4 | 1576h | 1576h | LTE_CA_B1_B26-Core | 30 | 36.101; 36.104; 36.133; new generic 36.851 | KDDI | Masaaki Obara (ms-obara@kddi.com) | Rel-12 | 58 | Issam | CA | LTE_CA_B1_B26-Core | RP-131005 |
| 4998 | 1700.16.2 | Perf. part:LTE Advanced inter-band Carrier Aggregation of Band 1 and Band 26 | 200d? | 2012-12-07 A | 2013-09-06 A | 100% | 2012-12-07 | 2013-09-06 | 200d? | finish no earlier than 2013-09-06 | R4 | 1600h | 1600h | LTE_CA_B1_B26-Perf | 30 | 36.141; 36.307 | KDDI | Masaaki Obara (ms-obara@kddi.com) | Rel-12 | 58 | Issam | CA | LTE_CA_B1_B26-Perf | RP-131006 |
| 4999 | 1700.17 | **LTE Advanced inter-band Carrier Aggregation of Band 39 and Band 41** | 330d? | 2012-12-10 A | 2014-03-06 A | 100% | 2012-12-10 | 2014-03-06 | 330d? |  | R4 | 7848h | 7848h | LTE_CA_B39_B41 | 30 | LTE | China Mobile | Pan Qun (panqun@chinamobile.com) | Rel-12 | 58 | Issam | CA | LTE_CA_B39_B41 | RP-140428 |
| 5000 | 1700.17.1 | Core part:LTE Advanced inter-band Carrier Aggregation of Band 39 and Band 41 | 326d? | 2012-12-10 A | 2014-03-06 A | 100% | 2012-12-10 | 2014-03-06 | 326d? | finish no earlier than 2014-03-06 | R4 | 2608h | 2608h | LTE_CA_B39_B41-Core | 30 | 36.101; 36.104; 36.307; new generic 36.851 | China Mobile | Pan Qun (panqun@chinamobile.com) | Rel-12 | 58 | Issam | CA | LTE_CA_B39_B41-Core | RP-140428 |
| 5001 | 1700.17.2 | Perf. part:LTE Advanced inter-band Carrier Aggregation of Band 39 and Band 41 | 325d? | 2012-12-14 A | 2014-03-06 A | 100% | 2012-12-14 | 2014-03-06 | 325d? | finish no earlier than 2014-03-06 | R4 | 2600h | 2600h | LTE_CA_B39_B41-Perf | 30 | 36.133; 36.141 | China Mobile | Pan Qun (panqun@chinamobile.com) | Rel-12 | 58 | Issam | CA | LTE_CA_B39_B41-Perf | RP-140428 |
| 5002 | 1700.18 | **LTE Advanced inter-band Carrier Aggregation of Band 2 and Band 12** | 467d? | 2012-12-10 A | 2014-09-12 A | 100% | 2012-12-10 | 2014-09-12 | 466d? |  | R4 | 10040h | 10040h | LTE_CA_B2_B12 | 30 | LTE | US Cellular | sebastian.thalanany@uscellular.com | Rel-12 | 58 | Issam | CA | LTE_CA_B2_B12 |  |
| 5003 | 1700.18.1 | Core part:LTE Advanced inter-band Carrier Aggregation of Band 2 and Band 12 | 464d? | 2012-12-10 A | 2014-09-12 A | 100% | 2012-12-10 | 2014-09-12 | 464d? | finish no earlier than 2014-09-12 | R4 | 3704h | 3704h | LTE_CA_B2_B12-Core | 30 | 36.101; 36.104; 36.133; 36.141; 36.307; new generic 36.851 | US Cellular | sebastian.thalanany@uscellular.com | Rel-12 | 58 | Issam | CA | LTE_CA_B2_B12-Core | RP-141084 |
| 5004 | 1700.18.2 | Perf. part:LTE Advanced inter-band Carrier Aggregation of Band 2 and Band 12 | 325d? | 2012-12-14 A | 2014-03-06 A | 100% | 2012-12-14 | 2014-03-06 | 325d? | finish no earlier than 2014-06-13 | R4 | 2600h | 2600h | LTE_CA_B2_B12-Perf | 30 | 36.101; 36.104; 36.133; 36.141; 36.307 | US Cellular | sebastian.thalanany@uscellular.com | Rel-12 | 58 | Issam | CA | LTE_CA_B2_B12-Perf | RP-140428 |
| 5005 | 1700.19 | **LTE Advanced intra-band non-contiguous Carrier Aggregation in Band 7** | 265d? | 2012-12-10 A | 2013-12-06 A | 100% | 2012-12-10 | 2013-12-06 | 265d? |  | R4 | 6296h | 6296h | LTE_CA_NC_B7 | 30 | LTE | Ericsson | christian.bergljung@ericsson.com | Rel-12 | 58 | Issam | CA | LTE_CA_NC_B7 |  |
| 5006 | 1700.19.1 | Core part:LTE Advanced intra-band non-contiguous Carrier Aggregation in Band 7 | 261d? | 2012-12-10 A | 2013-12-06 A | 100% | 2012-12-10 | 2013-12-06 | 261d? | finish no earlier than 2013-12-06 | R4 | 2088h | 2088h | LTE_CA_NC_B7-Core | 30 | 36.101; 36.104; 36.133; new 36.833-2-07 | Ericsson | christian.bergljung@ericsson.com | Rel-12 | 58 | Issam | CA | LTE_CA_NC_B7-Core | RP-131575 |
| 5007 | 1700.19.2 | Perf. part:LTE Advanced intra-band non-contiguous Carrier Aggregation in Band 7 | 261d? | 2012-12-14 A | 2013-12-06 A | 100% | 2012-12-14 | 2013-12-06 | 261d? | finish no earlier than 2013-12-06 | R4 | 2088h | 2088h | LTE_CA_NC_B7-Perf | 30 | 36.141; 36.307 | Ericsson | christian.bergljung@ericsson.com | Rel-12 | 58 | Issam | CA | LTE_CA_NC_B7-Perf | RP-131576 |
| 5008 | 1700.20 | **LTE Advanced intra-band contiguous Carrier Aggregation in Band 27** | 401d? | 2012-12-10 A | 2014-06-13 A | 100% | 2012-12-10 | 2014-06-13 | 401d? |  | R4 | 8472h | 8472h | LTE_CA_C_B27 | 30 | LTE | NII Holdings | bill.shvodian@nii.com | Rel-12 | 58 | Issam | CA | LTE_CA_C_B27 |  |
| 5009 | 1700.20.1 | Core part: LTE Advanced intra-band contiguous Carrier Aggregation in Band 27 | 261d? | 2012-12-10 A | 2013-12-06 A | 100% | 2012-12-10 | 2013-12-06 | 261d? | finish no earlier than 2013-12-06 | R4 | 2088h | 2088h | LTE_CA_C_B27-Core | 30 | 36.101; 36.104; new 36.833-1-27 | NII Holdings | bill.shvodian@nii.com | Rel-12 | 58 | Issam | CA | LTE_CA_C_B27-Core | RP-131567 |
| 5010 | 1700.20.2 | Perf part: LTE Advanced intra-band contiguous Carrier Aggregation in Band 27 | 397d? | 2012-12-14 A | 2014-06-13 A | 100% | 2012-12-14 | 2014-06-13 | 397d? | finish no earlier than 2014-06-13 | R4 | 3176h | 3176h | LTE_CA_C_B27-Perf | 30 | 36.101; 36.133; 36.141; 36.307; new 36.833-1-27 | NII Holdings | bill.shvodian@nii.com | Rel-12 | 58 | Issam | CA | LTE_CA_C_B27-Perf | RP-140569 |
| 5011 | 1700.21 | **LTE Advanced inter-band Carrier Aggregation of Band 2 and Band 13** | 76d? | 2013-03-04 A | 2013-06-14 A | 100% | 2013-03-04 | 2013-06-14 | 76d? |  | R4 | 1824h | 1824h | LTE_CA_B2_B13 | 30 | LTE | Ericsson | christian.bergljung@ericsson.com | Rel-12 | 59 | Issam | CA | LTE_CA_B2_B13 |  |
| 5012 | 1700.21.1 | Core part:LTE Advanced inter-band Carrier Aggregation of Band 2 and Band 13 | 76d? | 2013-03-04 A | 2013-06-14 A | 100% | 2013-03-04 | 2013-06-14 | 76d? | finish no earlier than 2013-06-14 | R4 | 608h | 608h | LTE_CA_B2_B13-Core | 30 | 36.101; 36.104; 36.133; new generic 36.851 | Ericsson | christian.bergljung@ericsson.com | Rel-12 | 59 | Issam | CA | LTE_CA_B2_B13-Core | RP-130523 |
| 5013 | 1700.21.2 | Perf. part:LTE Advanced inter-band Carrier Aggregation of Band 2 and Band 13 | 76d? | 2013-03-04 A | 2013-06-14 A | 100% | 2013-03-04 | 2013-06-14 | 76d? | finish no earlier than 2013-06-14 | R4 | 608h | 608h | LTE_CA_B2_B13-Perf | 30 | 36.101; 36.104; 36.133; 36.141; 36.307 | Ericsson | christian.bergljung@ericsson.com | Rel-12 | 59 | Issam | CA | LTE_CA_B2_B13-Perf | RP-130524 |

Notes:
- 4990: Inter-band 1 UL
- 4991: RP#60 completed
- 4992: RP#60 completed
- 4993: Inter-band 1 UL
- 4994: RP#60 completed
- 4995: RP#60 completed
- 4996: Inter-band 1UL/2DL
- 4997: RP#61 completed
- 4998: RP#61 completed
- 4999: Inter-band 2DL
- 5000: RP#63 completed. Replaces the Stopped WI - LTE Advanced inter-band Carrier Aggregation of Band 38 and Band 39 (LTE_CA_B38_B39) UID_570015
- 5001: RP#63 completed
- 5002: Inter-band CA 2DL
- 5003: RP#65 completed
- 5004: RP#63 completed
- 5005: Intra-band NC
- 5006: RP#62 completed
- 5007: RP#62 completed
- 5008: Intra-band contig. CA 2DL/1UL
- 5009: RP#62 completed
- 5010: RP#64 completed. TR 36.833-1-27v200 for Approval
- 5011: Inter-band 1 UL
- 5012: RP#60 completed
- 5013: RP#60 completed

| ID | WBS | Task | Duration | Start | Finish | Complete | Baseline start | Baseline finish | Baseline duration | Constraint | Resources | Work | Actual work | Acronym | PCG approved | Impacted TSs and TRs | WI rapporteur name | WI rapporteur e-mail | Release | TSG approved | MCC resp | Special Focus Doc | Acronym_3GU_Export | Status Report | PCG stopped | TSG stopped |
| --- | --- | --- | --- | --- | --- | --- | --- | --- | --- | --- | --- | --- | --- | --- | --- | --- | --- | --- | --- | --- | --- | --- | --- | --- | --- | --- |
| 5014 | 1700.22 | **LTE Advanced inter-band Carrier Aggregation of Band 19 and Band 21** | 76d? | 2013-03-04 A | 2013-06-14 A | 100% | 2013-03-04 | 2013-06-14 | 76d? |  | R4 | 1824h | 1824h | LTE_CA_B19_B21 | 30 | LTE | NTT DOCOMO | Kei ANDO | Rel-12 | 59 | Issam | CA | LTE_CA_B19_B21 |  |  |  |
| 5015 | 1700.22.1 | Core part:LTE Advanced inter-band Carrier Aggregation of Band 19 and Band 21 | 76d? | 2013-03-04 A | 2013-06-14 A | 100% | 2013-03-04 | 2013-06-14 | 76d? | finish no earlier than 2013-06-14 | R4 | 608h | 608h | LTE_CA_B19_B21-Core | 30 | 36.101; 36.104; 36.133; new generic 36.851 | NTT DOCOMO | Kei ANDO | Rel-12 | 59 | Issam | CA | LTE_CA_B19_B21-Core | RP-130533 |  |  |
| 5016 | 1700.22.2 | Perf. part:LTE Advanced inter-band Carrier Aggregation of Band 19 and Band 21 | 76d? | 2013-03-04 A | 2013-06-14 A | 100% | 2013-03-04 | 2013-06-14 | 76d? | finish no earlier than 2013-06-14 | R4 | 608h | 608h | LTE_CA_B19_B21-Perf | 30 | 36.141; 36.307 | NTT DOCOMO | Kei ANDO | Rel-12 | 59 | Issam | CA | LTE_CA_B19_B21-Perf | RP-130534 |  |  |
| 5017 | 1700.23 | **Deleted -LTE Advanced inter-band Carrier Aggregation of Band 8 and Band 26** | 204d? | 2013-03-04 A | 2013-12-06 A | 100% | 2013-03-04 | 2013-12-06 | 204d? |  | R4 | 4848h | 4848h | LTE_CA_B8_B26 | 30 | LTE | KT | Chungwoo HWANG (cwhwang@kt.com) | Rel-12 | 59 | Issam | CA | LTE_CA_B8_B26 |  | PCG-32 | RP-62 |
| 5018 | 1700.23.1 | Deleted - Core part:LTE Advanced inter-band Carrier Aggregation of Band 8 and Band 26 | 201d? | 2013-03-04 A | 2013-12-06 A | 100% | 2013-03-04 | 2013-12-06 | 201d? | finish no earlier than 2013-12-06 | R4 | 1608h | 1608h | LTE_CA_B8_B26-Core | 30 | 36.101; 36.104; 36.133; new generic 36.851 | KT | Chungwoo HWANG (cwhwang@kt.com) | Rel-12 | 59 | Issam | CA | LTE_CA_B8_B26-Core | RP-131549 | PCG-32 | RP-62 |
| 5019 | 1700.23.2 | Deleted - Perf. part:LTE Advanced inter-band Carrier Aggregation of Band 8 and Band 26 | 201d? | 2013-03-04 A | 2013-12-06 A | 100% | 2013-03-04 | 2013-12-06 | 201d? | finish no earlier than 2013-12-06 | R4 | 1608h | 1608h | LTE_CA_B8_B26-Perf | 30 | 36.141; 36.307 | KT | Chungwoo HWANG (cwhwang@kt.com) | Rel-12 | 59 | Issam | CA | LTE_CA_B8_B26-Perf | RP-131550 | PCG-32 | RP-62 |
| 5020 | 1700.24 | **LTE Advanced dual uplink inter-band Carrier Aggregation Class A1** | 474d? | 2013-03-04 A | 2014-12-15 A | 100% | 2013-03-04 | 2014-09-12 | 405d? |  | R4 | 11272h | 11272h | LTE_CA_2UL-A1 | 30 | LTE | Huawei | Liu Ye (leo.liuye@huawei.com) | Rel-12 | 59 | Issam | CA | LTE_CA_2UL-A1 |  |  |  |
| 5021 | 1700.24.1 | Core part:LTE Advanced dual uplink inter-band Carrier Aggregation Class A1 | 468d? | 2013-03-04 A | 2014-12-15 A | 100% | 2013-03-04 | 2014-09-12 | 402d? | finish no earlier than 2014-12-15 | R4 | 3744h | 3744h | LTE_CA_2UL-A1-Core | 30 | 36.101; 36.104; New generic 36.860 | Huawei | Liu Ye (leo.liuye@huawei.com) | Rel-12 | 59 | Issam | CA | LTE_CA_2UL-A1-Core | RP-141732 |  |  |
| 5022 | 1700.24.2 | Perf. part:LTE Advanced dual uplink inter-band Carrier Aggregation Class A1 | 467d? | 2013-03-13 A | 2014-12-15 A | 100% | 2013-03-08 | 2014-09-12 | 401d? | finish no earlier than 2014-12-15 | R4 | 3736h | 3736h | LTE_CA_2UL-A1-Perf | 30 | 36.133 | Huawei | Liu Ye (leo.liuye@huawei.com) | Rel-12 | 59 | Issam | CA | LTE_CA_2UL-A1-Perf | RP-141732 |  |  |
| 5023 | 1700.25 | **LTE Advanced dual uplink inter-band Carrier Aggregation Class A2** | 474d? | 2013-03-04 A | 2014-12-15 A | 100% | 2013-03-04 | 2014-09-12 | 405d? |  | R4 | 11272h | 11272h | LTE_CA_2UL-A2 | 30 | LTE | Qualcomm | Gene Fong (gfong@qti.qualcomm.com) | Rel-12 | 59 | Issam | CA | LTE_CA_2UL-A2 |  |  |  |
| 5024 | 1700.25.1 | Core part:LTE Advanced dual uplink inter-band Carrier Aggregation Class A2 | 468d? | 2013-03-04 A | 2014-12-15 A | 100% | 2013-03-04 | 2014-09-12 | 402d? | finish no earlier than 2014-12-15 | R4 | 3744h | 3744h | LTE_CA_2UL-A2-Core | 30 | 36.101; 36.104; 36.133; New generic 36.860 | Qualcomm | Gene Fong (gfong@qti.qualcomm.com) | Rel-12 | 59 | Issam | CA | LTE_CA_2UL-A2-Core | RP-141732 |  |  |
| 5025 | 1700.25.2 | Perf. part:LTE Advanced dual uplink inter-band Carrier Aggregation Class A2 | 467d? | 2013-03-13 A | 2014-12-15 A | 100% | 2013-03-08 | 2014-09-12 | 401d? | finish no earlier than 2014-12-15 | R4 | 3736h | 3736h | LTE_CA_2UL-A2-Perf | 30 | 36.141; 36.307 | Qualcomm | Gene Fong (gfong@qti.qualcomm.com) | Rel-12 | 59 | Issam | CA | LTE_CA_2UL-A2-Perf | RP-141732 |  |  |
| 5026 | 1700.26 | **LTE Advanced dual uplink inter-band Carrier Aggregation Class A3** | 474d? | 2013-03-04 A | 2014-12-15 A | 100% | 2013-03-04 | 2014-09-12 | 405d? |  | R4 | 11264h | 11264h | LTE_CA_2UL-A3 | 30 | LTE | Ericsson | christian.bergljung@ericsson.com | Rel-12 | 59 | Issam | CA | LTE_CA_2UL-A3 |  |  |  |
| 5027 | 1700.26.1 | Core part:LTE Advanced dual uplink inter-band Carrier Aggregation Class A3 | 467d? | 2013-03-04 A | 2014-12-15 A | 100% | 2013-03-04 | 2014-09-12 | 401d? | finish no earlier than 2014-12-15 | R4 | 3736h | 3736h | LTE_CA_2UL-A3-Core | 30 | 36.101; 36.104; 36.133; New generic 36.860 | Ericsson | christian.bergljung@ericsson.com | Rel-12 | 59 | Issam | CA | LTE_CA_2UL-A3-Core | RP-141732 |  |  |
| 5028 | 1700.26.2 | Perf. part:LTE Advanced dual uplink inter-band Carrier Aggregation Class A3 | 467d? | 2013-03-13 A | 2014-12-15 A | 100% | 2013-03-08 | 2014-09-12 | 401d? | finish no earlier than 2014-12-15 | R4 | 3736h | 3736h | LTE_CA_2UL-A3-Perf | 30 | 36.141; 36.307 | Ericsson | christian.bergljung@ericsson.com | Rel-12 | 59 | Issam | CA | LTE_CA_2UL-A3-Perf | RP-141732 |  |  |
| 5029 | 1700.27 | **LTE Advanced dual uplink inter-band Carrier Aggregation Class A4** | 474d? | 2013-03-04 A | 2014-12-15 A | 100% | 2013-03-04 | 2014-09-12 | 405d? |  | R4 | 11272h | 11272h | LTE_CA_2UL-A4 | 30 | LTE | Nokia | petri.j.vasenkari@nokia.com | Rel-12 | 59 | Issam | CA | LTE_CA_2UL-A4 |  |  |  |
| 5030 | 1700.27.1 | Core part:LTE Advanced dual uplink inter-band Carrier Aggregation Class A4 | 468d? | 2013-03-04 A | 2014-12-15 A | 100% | 2013-03-04 | 2014-09-12 | 402d? | finish no earlier than 2014-12-15 | R4 | 3744h | 3744h | LTE_CA_2UL-A4-Core | 30 | 36.101; 36.104; 36.133; New generic 36.860 | Nokia | petri.j.vasenkari@nokia.com | Rel-12 | 59 | Issam | CA | LTE_CA_2UL-A4-Core | RP-141732 |  |  |
| 5031 | 1700.27.2 | Perf. part:LTE Advanced dual uplink inter-band Carrier Aggregation Class A4 | 467d? | 2013-03-13 A | 2014-12-15 A | 100% | 2013-03-08 | 2014-09-12 | 401d? | finish no earlier than 2014-12-15 | R4 | 3736h | 3736h | LTE_CA_2UL-A4-Perf | 30 | 36.141; 36.307 | Nokia | petri.j.vasenkari@nokia.com | Rel-12 | 59 | Issam | CA | LTE_CA_2UL-A4-Perf | RP-141732 |  |  |
| 5032 | 1700.28 | **LTE Advanced dual uplink inter-band Carrier Aggregation Class A5** | 474d? | 2013-03-04 A | 2014-12-15 A | 100% | 2013-03-04 | 2014-09-12 | 405d? |  | R4 | 11264h | 11264h | LTE_CA_2UL-A5 | 30 | LTE | NTT DOCOMO | kei.andou.ye@nttdocomo.com | Rel-12 | 59 | Issam | CA | LTE_CA_2UL-A5 |  |  |  |
| 5033 | 1700.28.1 | Core part:LTE Advanced dual uplink inter-band Carrier Aggregation Class A5 | 467d? | 2013-03-04 A | 2014-12-15 A | 100% | 2013-03-04 | 2014-09-12 | 401d? | finish no earlier than 2014-12-15 | R4 | 3736h | 3736h | LTE_CA_2UL-A5-Core | 30 | 36.101; 36.104; 36.133; New generic 36.860 | NTT DOCOMO | kei.andou.ye@nttdocomo.com | Rel-12 | 59 | Issam | CA | LTE_CA_2UL-A5-Core | RP-141732 |  |  |
| 5034 | 1700.28.2 | Perf. part:LTE Advanced dual uplink inter-band Carrier Aggregation Class A5 | 467d? | 2013-03-13 A | 2014-12-15 A | 100% | 2013-03-08 | 2014-09-12 | 401d? | finish no earlier than 2014-12-15 | R4 | 3736h | 3736h | LTE_CA_2UL-A5-Perf | 30 | 36.141; 36.307 | NTT DOCOMO | kei.andou.ye@nttdocomo.com | Rel-12 | 59 | Issam | CA | LTE_CA_2UL-A5-Perf | RP-141732 |  |  |
| 5035 | 1700.29 | **LTE Advanced intra-band contiguous Carrier Aggregation in Band 39** | 269d? | 2013-03-04 A | 2014-03-06 A | 100% | 2013-03-04 | 2014-03-06 | 269d? |  | R4 | 6400h | 6400h | LTE_CA_C_B39 | 30 | LTE | China Mobile | Li Nan (linan@chinamobile.com) | Rel-12 | 59 | Issam | CA | LTE_CA_C_B39 |  |  |  |
| 5036 | 1700.29.1 | Core part: LTE Advanced intra-band contiguous Carrier Aggregation in Band 39 | 266d? | 2013-03-04 A | 2014-03-06 A | 100% | 2013-03-04 | 2014-03-06 | 266d? | finish no earlier than 2014-03-06 | R4 | 2128h | 2128h | LTE_CA_C_B39-Core | 30 | 36.101; 36.104; 36.133; New 36.833-1-39 [instead of 36.845] | China Mobile | Li Nan (linan@chinamobile.com) | Rel-12 | 59 | Issam | CA | LTE_CA_C_B39-Core | RP-140428 |  |  |
| 5037 | 1700.29.2 | Perf. part: LTE Advanced intra-band contiguous Carrier Aggregation in Band 39 | 265d? | 2013-03-07 A | 2014-03-06 A | 100% | 2013-03-07 | 2014-03-06 | 265d? | finish no earlier than 2014-03-06 | R4 | 2120h | 2120h | LTE_CA_C_B39-Perf | 30 | 36.141; 36.307 | China Mobile | Li Nan (linan@chinamobile.com) | Rel-12 | 59 | Issam | CA | LTE_CA_C_B39-Perf | RP-140428 |  |  |

Notes:
- 5014: Inter-band 1 UL
- 5015: RP#60 completed
- 5016: RP#60 completed
- 5017: Inter-band 1 UL
- 5018: RP#62 stopped (at 20%)
- 5019: RP#62 stopped (at 20%)
- 5020: Inter-band CA 2UL
- 5021: ¦WID: RP-142043->RP-141941¦Stat Rep: RP-141084->RP-141732
- 5022: ¦WID: RP-142043->RP-141941¦Stat Rep: RP-141084->RP-141732
- 5023: Inter-band CA 2UL
- 5024: ¦Stat Rep: RP-141084->RP-141732
- 5025: ¦Stat Rep: RP-141084->RP-141732
- 5026: Inter-band CA 2UL
- 5027: ¦Stat Rep: RP-141084->RP-141732
- 5028: ¦Stat Rep: RP-141084->RP-141732
- 5029: Inter-band CA 2UL. RP#65 updated WID RP-140476=>RP-141160.
- 5030: ¦WID: RP-142043->RP-141967¦Stat Rep: RP-141084->RP-141732
- 5031: ¦WID: RP-142043->RP-141967¦Stat Rep: RP-141084->RP-141732
- 5032: Inter-band CA 2UL. RP#65 updated WID RP-131146=>RP-141195. Changed Rapp Renesas=>Broadcom=>NTT DOCOMO
- 5033: ¦Stat Rep: RP-141084->RP-141732
- 5034: ¦Stat Rep: RP-141084->RP-141732
- 5035: Intra-band C 2DL/2UL
- 5036: RP#63 completed
- 5037: RP#63 completed

| ID | WBS | Task | Duration | Start | Finish | Complete | Baseline start | Baseline finish | Baseline duration | Constraint | Resources | Work | Actual work | Acronym | PCG approved | WI rapporteur name | WI rapporteur e-mail | Release | TSG approved | MCC resp | Special Focus Doc | Acronym_3GU_Export | Status Report | PCG stopped | TSG stopped |
| --- | --- | --- | --- | --- | --- | --- | --- | --- | --- | --- | --- | --- | --- | --- | --- | --- | --- | --- | --- | --- | --- | --- | --- | --- | --- |
| 5038 | 1700.30 | **LTE Advanced intra-band non-contiguous Carrier Aggregation: framework requirements for 2UL** | 397d? | 2013-06-18 A | 2014-12-15 A | 100% | 2013-06-18 | 2014-09-12 | 328d? |  | R4 | 6328h | 6328h | LTE_CA_NC_2UL | 31 | Nokia | petri.j.vasenkari@nokia.com | Rel-12 | 60 | Issam | CA | LTE_CA_NC_2UL |  |  |  |
| 5039 | 1700.30.1 | Core part:LTE Advanced intra-band non-contiguous Carrier Aggregation: framework requirements for 2UL | 394d? | 2013-06-18 A | 2014-12-15 A | 100% | 2013-06-18 | 2014-09-12 | 328d? | finish no earlier than 2014-12-15 | R4 | 3152h | 3152h | LTE_CA_NC_2UL-Core | 31 | Nokia | petri.j.vasenkari@nokia.com | Rel-12 | 60 | Issam | CA | LTE_CA_NC_2UL-Core | RP-141732 |  |  |
| 5040 | 1700.31 | **Deleted -LTE Advanced intra-band non-contiguous Carrier Aggregation in Band 41 for 2UL** | 191d? | 2013-06-19 A | 2014-03-06 A | 100% | 2013-06-19 | 2014-03-06 | 191d? |  | R4 | 4576h | 4576h | LTE_CA_NC_B41_2UL | 31 | Sprint | yang.xu@clearwire.com | Rel-12 | 60 | Issam | CA | LTE_CA_NC_B41_2UL | RP-140428 | PCG-32 | RP-63 |
| 5041 | 1700.31.1 | Deleted - Core part:LTE Advanced intra-band non-contiguous Carrier Aggregation in Band 41 for 2UL | 191d? | 2013-06-19 A | 2014-03-06 A | 100% | 2013-06-19 | 2014-03-06 | 191d? | finish no earlier than 2014-03-06 | R4 | 1528h | 1528h | LTE_CA_NC_B41_2UL-Core | 31 | Sprint | yang.xu@clearwire.com | Rel-12 | 60 | Issam | CA | LTE_CA_NC_B41_2UL-Core | RP-140428 | PCG-32 | RP-63 |
| 5042 | 1700.31.2 | Deleted - Perf. part:LTE Advanced intra-band non-contiguous Carrier Aggregation in Band 41 for 2UL | 190d? | 2013-06-20 A | 2014-03-06 A | 100% | 2013-06-20 | 2014-03-06 | 190d? | finish no earlier than 2014-03-06 | R4 | 1520h | 1520h | LTE_CA_NC_B41_2UL-Perf | 31 | Sprint | yang.xu@clearwire.com | Rel-12 | 60 | Issam | CA | LTE_CA_NC_B41_2UL-Perf | RP-140428 | PCG-32 | RP-63 |
| 5043 | 1700.32 | **LTE Advanced intra-band non-contiguous Carrier Aggregation in Band 4 for 2UL** | 396d? | 2013-06-19 A | 2014-12-15 A | 100% | 2013-06-19 | 2014-09-12 | 327d? |  | R4 | 9448h | 9448h | LTE_CA_NC_B4_2UL | 31 | T-Mobile USA | nelson.ueng@t-mobile.com | Rel-12 | 60 | Issam | CA | LTE_CA_NC_B4_2UL |  |  |  |
| 5044 | 1700.32.1 | Core part:LTE Advanced intra-band non-contiguous Carrier Aggregation in Band 4 for 2UL | 393d? | 2013-06-19 A | 2014-12-15 A | 100% | 2013-06-19 | 2014-09-12 | 327d? | finish no earlier than 2014-12-15 | R4 | 3144h | 3144h | LTE_CA_NC_B4_2UL-Core | 31 | T-Mobile USA | nelson.ueng@t-mobile.com | Rel-12 | 60 | Issam | CA | LTE_CA_NC_B4_2UL-Core | RP-141732 |  |  |
| 5045 | 1700.32.2 | Perf. part:LTE Advanced intra-band non-contiguous Carrier Aggregation in Band 4 for 2UL | 392d? | 2013-06-25 A | 2014-12-15 A | 100% | 2013-06-20 | 2014-09-12 | 326d? | finish no earlier than 2014-12-15 | R4 | 3136h | 3136h | LTE_CA_NC_B4_2UL-Perf | 31 | T-Mobile USA | nelson.ueng@t-mobile.com | Rel-12 | 60 | Issam | CA | LTE_CA_NC_B4_2UL-Perf | RP-141732 |  |  |
| 5046 | 1700.33 | **LTE Advanced intra-band contiguous Carrier Aggregation in Band 23** | 127d? | 2013-06-18 A | 2013-12-06 A | 100% | 2013-06-18 | 2013-12-06 | 127d? |  | R4 | 3032h | 3032h | LTE_CA_C_B23 | 31 | Dish Network | mariam.sorond@dish.com, johny.kim@dish.com | Rel-12 | 60 | Issam | CA | LTE_CA_C_B23 |  |  |  |
| 5047 | 1700.33.1 | Core part: LTE Advanced intra-band contiguous Carrier Aggregation in Band 23 | 126d? | 2013-06-18 A | 2013-12-06 A | 100% | 2013-06-18 | 2013-12-06 | 126d? | finish no earlier than 2013-12-06 | R4 | 1008h | 1008h | LTE_CA_C_B23-Core | 31 | Dish Network | mariam.sorond@dish.com, johny.kim@dish.com | Rel-12 | 60 | Issam | CA | LTE_CA_C_B23-Core | RP-131565 |  |  |
| 5048 | 1700.33.2 | Perf. part: LTE Advanced intra-band contiguous Carrier Aggregation in Band 23 | 126d? | 2013-06-18 A | 2013-12-06 A | 100% | 2013-06-18 | 2013-12-06 | 126d? | finish no earlier than 2013-12-06 | R4 | 1008h | 1008h | LTE_CA_C_B23-Perf | 31 | Dish Network | mariam.sorond@dish.com, johny.kim@dish.com | Rel-12 | 60 | Issam | CA | LTE_CA_C_B23-Perf | RP-131566 |  |  |
| 5049 | 1700.34 | **LTE Advanced intra-band non-contiguous Carrier Aggregation in Band 23** | 263d? | 2013-06-18 A | 2014-06-13 A | 100% | 2013-06-18 | 2014-06-13 | 263d? |  | R4 | 5216h | 5216h | LTE_CA_NC_B23 | 31 | Dish Network | mariam.sorond@dish.com, johny.kim@dish.com | Rel-12 | 60 | Issam | CA | LTE_CA_NC_B23 |  |  |  |
| 5050 | 1700.34.1 | Core part:LTE Advanced intra-band non-contiguous Carrier Aggregation in Band 23 | 126d? | 2013-06-18 A | 2013-12-06 A | 100% | 2013-06-18 | 2013-12-06 | 126d? | finish no earlier than 2013-12-06 | R4 | 1008h | 1008h | LTE_CA_NC_B23-Core | 31 | Dish Network | mariam.sorond@dish.com, johny.kim@dish.com | Rel-12 | 60 | Issam | CA | LTE_CA_NC_B23-Core | RP-131577 |  |  |
| 5051 | 1700.34.2 | Perf. part:LTE Advanced intra-band non-contiguous Carrier Aggregation in Band 23 | 263d? | 2013-06-18 A | 2014-06-13 A | 100% | 2013-06-18 | 2014-06-13 | 263d? | finish no earlier than 2014-06-13 | R4 | 2104h | 2104h | LTE_CA_NC_B23-Perf | 31 | Dish Network | mariam.sorond@dish.com, johny.kim@dish.com | Rel-12 | 60 | Issam | CA | LTE_CA_NC_B23-Perf | RP-140569 |  |  |
| 5052 | 1700.35 | **LTE Advanced inter-band Carrier Aggregation of Band 12 and Band 25** | 127d? | 2013-06-18 A | 2013-12-06 A | 100% | 2013-06-18 | 2013-12-06 | 127d? |  | R4 | 3032h | 3032h | LTE_CA_B12_B25 | 31 | US Cellular | sebastian.thalanany@uscellular.com | Rel-12 | 60 | Issam | CA | LTE_CA_B12_B25 |  |  |  |
| 5053 | 1700.35.1 | Core part:LTE Advanced inter-band Carrier Aggregation of Band 12 and Band 25 | 126d? | 2013-06-18 A | 2013-12-06 A | 100% | 2013-06-18 | 2013-12-06 | 126d? | finish no earlier than 2013-12-06 | R4 | 1008h | 1008h | LTE_CA_B12_B25-Core | 31 | US Cellular | sebastian.thalanany@uscellular.com | Rel-12 | 60 | Issam | CA | LTE_CA_B12_B25-Core | RP-131705 |  |  |
| 5054 | 1700.35.2 | Perf. part:LTE Advanced inter-band Carrier Aggregation of Band 12 and Band 25 | 126d? | 2013-06-19 A | 2013-12-06 A | 100% | 2013-06-19 | 2013-12-06 | 126d? | finish no earlier than 2013-12-06 | R4 | 1008h | 1008h | LTE_CA_B12_B25-Perf | 31 | US Cellular | sebastian.thalanany@uscellular.com | Rel-12 | 60 | Issam | CA | LTE_CA_B12_B25-Perf | RP-131706 |  |  |
| 5055 | 1700.36 | **LTE Advanced inter-band Carrier Aggregation of Band 1 and Band 18 - Additional bandwidth combination set** | 61d? | 2013-06-18 A | 2013-09-06 A | 100% | 2013-06-18 | 2013-09-06 | 61d? |  | R4 | 1464h | 1464h | LTE_CA_B1_B18_BWset | 31 | KDDI | Masaaki Obara (ms-obara@kddi.com) | Rel-12 | 60 | Issam | CA | LTE_CA_B1_B18_BWset |  |  |  |
| 5056 | 1700.36.1 | Core part:LTE Advanced inter-band Carrier Aggregation of Band 1 and Band 18 - Additional bandwidth combination set | 61d? | 2013-06-18 A | 2013-09-06 A | 100% | 2013-06-18 | 2013-09-06 | 61d? | finish no earlier than 2013-09-06 | R4 | 488h | 488h | LTE_CA_B1_B18_BWset-Core | 31 | KDDI | Masaaki Obara (ms-obara@kddi.com) | Rel-12 | 60 | Issam | CA | LTE_CA_B1_B18_BWset-Core | RP-131003 |  |  |
| 5057 | 1700.36.2 | Perf. part:LTE Advanced inter-band Carrier Aggregation of Band 1 and Band 18 - Additional bandwidth combination set | 61d? | 2013-06-18 A | 2013-09-06 A | 100% | 2013-06-18 | 2013-09-06 | 61d? | finish no earlier than 2013-09-06 | R4 | 488h | 488h | LTE_CA_B1_B18_BWset-Perf | 31 | KDDI | Masaaki Obara (ms-obara@kddi.com) | Rel-12 | 60 | Issam | CA | LTE_CA_B1_B18_BWset-Perf | RP-131004 |  |  |
| 5058 | 1700.37 | **LTE Advanced inter-band Carrier Aggregation of Band 2 and Band 5** | 61d? | 2013-06-18 A | 2013-09-06 A | 100% | 2013-06-18 | 2013-09-06 | 61d? |  | R4 | 1464h | 1464h | LTE_CA_B2_B5 | 31 | AT&T | marc.grant@att.com | Rel-12 | 60 | Issam | CA | LTE_CA_B2_B5 |  |  |  |
| 5059 | 1700.37.1 | Core part:LTE Advanced inter-band Carrier Aggregation of Band 2 and Band 5 | 61d? | 2013-06-18 A | 2013-09-06 A | 100% | 2013-06-18 | 2013-09-06 | 61d? | finish no earlier than 2013-09-06 | R4 | 488h | 488h | LTE_CA_B2_B5-Core | 31 | AT&T | marc.grant@att.com | Rel-12 | 60 | Issam | CA | LTE_CA_B2_B5-Core | RP-131009 |  |  |
| 5060 | 1700.37.2 | Perf. part:LTE Advanced inter-band Carrier Aggregation of Band 2 and Band 5 | 61d? | 2013-06-18 A | 2013-09-06 A | 100% | 2013-06-18 | 2013-09-06 | 61d? | finish no earlier than 2013-12-06 | R4 | 488h | 488h | LTE_CA_B2_B5-Perf | 31 | AT&T | marc.grant@att.com | Rel-12 | 60 | Issam | CA | LTE_CA_B2_B5-Perf | RP-131010 |  |  |
| 5061 | 1700.38 | **LTE Advanced 3 Band Carrier Aggregation (3DL/1UL) of Band 2, Band 5 and Band 30** | 329d? | 2013-06-18 A | 2014-09-12 A | 100% | 2013-06-18 | 2014-09-12 | 328d? |  | R4 | 7872h | 7872h | LTE_CA_B2_B5_B30 | 31 | AT&T | marc.grant@att.com | Rel-12 | 60 | Issam | CA | LTE_CA_B2_B5_B30 |  |  |  |
| 5062 | 1700.38.1 | Core part:LTE Advanced 3 Band Carrier Aggregation (3DL/1UL) of Band 2, Band 5 and Band 30 | 328d? | 2013-06-18 A | 2014-09-12 A | 100% | 2013-06-18 | 2014-09-12 | 328d? | finish no earlier than 2014-09-12 | R4 | 2624h | 2624h | LTE_CA_B2_B5_B30-Core | 31 | AT&T | marc.grant@att.com | Rel-12 | 60 | Issam | CA | LTE_CA_B2_B5_B30-Core | RP-141084 |  |  |
| 5063 | 1700.38.2 | Perf. part:LTE Advanced 3 Band Carrier Aggregation (3DL/1UL) of Band 2, Band 5 and Band 30 | 327d? | 2013-06-18 A | 2014-09-12 A | 100% | 2013-06-18 | 2014-09-12 | 327d? | finish no earlier than 2014-09-12 | R4 | 2616h | 2616h | LTE_CA_B2_B5_B30-Perf | 31 | AT&T | marc.grant@att.com | Rel-12 | 60 | Issam | CA | LTE_CA_B2_B5_B30-Perf | RP-141084 |  |  |

Notes:
- 5038: Intra-band non-contig. CA 2DL / Impacted TSs and TRs: LTE
- 5039: ¦WID: RP-142043->RP-141962¦Stat Rep: RP-141084->RP-141732 / Impacted TSs and TRs: 36.101; 36.104; 36.133; 36.306; 36.331; New 36.833-4
- 5040: Intra-band NC 2UL / Impacted TSs and TRs: LTE
- 5041: RP#63 stopped (5% complete). Reason: Market conditions have eliminated the need for this feature, at least for the foreseeable future / Impacted TSs and TRs: 36.101; 36.104; 36.133; new 36.833-3-41
- 5042: RP#63 stopped (0% complete). / Impacted TSs and TRs: 36.101; 36.104; 36.133; 36.141; 36.307
- 5043: Intra-band non-contig. CA 2DL / Impacted TSs and TRs: LTE
- 5044: ¦WID: RP-142043->RP-141784¦Stat Rep: RP-141084->RP-141732 / Impacted TSs and TRs: 36.101; 36.104; 36.133; new 36.833-4-04
- 5045: ¦WID: RP-142043->RP-141784¦Stat Rep: RP-141084->RP-141732 / Impacted TSs and TRs: 36.101; 36.104; 36.133; 36.141; 36.307
- 5046: Intra-band C CA / Impacted TSs and TRs: LTE
- 5047: RP#62 completed / Impacted TSs and TRs: 36.101; 36.104; 36.133; new 36.833-1-23 [instead of 36.864]
- 5048: RP#62 completed / Impacted TSs and TRs: 36.141; 36.307
- 5049: Intra-band non-contig. CA 2DL / Impacted TSs and TRs: LTE
- 5050: RP#62 completed / Impacted TSs and TRs: 36.101; 36.104; 36.133; new 36.833-2-23
- 5051: RP#64 completed. TR 36.833-2-23v200 for Approval / Impacted TSs and TRs: 36.101; 36.133; 36.141; 36.307; new 36.833-2-23
- 5052: Inter-band 1UL/2DL / Impacted TSs and TRs: LTE
- 5053: RP#62 completed / Impacted TSs and TRs: 36.101; 36.104; 36.133; new generic 36.851
- 5054: RP#62 completed / Impacted TSs and TRs: 36.141; 36.307
- 5055: Inter-band 1UL/2DL / Impacted TSs and TRs: LTE
- 5056: RP#61 completed / Impacted TSs and TRs: 36.101; new generic 36.851
- 5057: RP#61 completed / Impacted TSs and TRs: 36.307
- 5058: Inter-band 2DL / Impacted TSs and TRs: LTE
- 5059: RP#61 completed / Impacted TSs and TRs: 36.101; 36.104; 36.307
- 5060: RP#61 completed / Impacted TSs and TRs: 36.101; 36.104; 36.133; 36.141; 36.307
- 5061: Inter-band 3DL / Impacted TSs and TRs: LTE
- 5062: RP#65 completed. TR 36.853v200 for Approval / Impacted TSs and TRs: 36.101; 36.104; 36.133; 36.141; 36.307; new generic 36.853 (3 Band CA with 1UL)
- 5063: RP#65 completed / Impacted TSs and TRs: 36.101; 36.104; 36.133; 36.141; 36.307

| ID | WBS | Task | Duration | Start | Finish | Complete | Baseline start | Baseline finish | Baseline duration | Constraint | Resources | Work | Actual work | Acronym | PCG approved | WI rapporteur name | WI rapporteur e-mail | Release | TSG approved | MCC resp | PCG stopped | TSG stopped | Special Focus Doc | Acronym_3GU_Export | Status Report |
| --- | --- | --- | --- | --- | --- | --- | --- | --- | --- | --- | --- | --- | --- | --- | --- | --- | --- | --- | --- | --- | --- | --- | --- | --- | --- |
| 5064 | 1700.39 | **Deleted -LTE Advanced 3 Band Carrier Aggregation (3DL/1UL) of Band 2, Band 17 and Band 30** | 127d? | 2013-06-18 A | 2013-12-06 A | 100% | 2013-06-18 | 2013-12-06 | 127d? |  | R4 | 3024h | 3024h | LTE_CA_B2_B17_B30 | 31 | AT&T | marc.grant@att.com | Rel-12 | 60 | Issam | PCG-32 | RP-62 | CA | LTE_CA_B2_B17_B30 |  |
| 5065 | 1700.39.1 | Deleted - Core part:LTE Advanced 3 Band Carrier Aggregation (3DL/1UL) of Band 2, Band 17 and Band 30 | 126d? | 2013-06-18 A | 2013-12-06 A | 100% | 2013-06-18 | 2013-12-06 | 126d? | finish no earlier than 2014-06-13 | R4 | 1008h | 1008h | LTE_CA_B2_B17_B30-Core | 31 | AT&T | marc.grant@att.com | Rel-12 | 60 | Issam | PCG-32 | RP-62 | CA | LTE_CA_B2_B17_B30-Core | RP-131590 |
| 5066 | 1700.39.2 | Deleted - Perf. part:LTE Advanced 3 Band Carrier Aggregation (3DL/1UL) of Band 2, Band 17 and Band 30 | 125d? | 2013-06-19 A | 2013-12-06 A | 100% | 2013-06-19 | 2013-12-06 | 125d? | finish no earlier than 2014-09-12 | R4 | 1000h | 1000h | LTE_CA_B2_B17_B30-Perf | 31 | AT&T | marc.grant@att.com | Rel-12 | 60 | Issam | PCG-32 | RP-62 | CA | LTE_CA_B2_B17_B30-Perf | RP-131591 |
| 5067 | 1700.40 | **LTE Advanced 3 Band Carrier Aggregation (3DL/1UL) of Band 2, Band 29 and Band 30** | 328d? | 2013-06-19 A | 2014-09-12 A | 100% | 2013-06-19 | 2014-09-12 | 327d? |  | R4 | 7856h | 7856h | LTE_CA_B2_B29_B30 | 31 | AT&T | marc.grant@att.com | Rel-12 | 60 | Issam |  |  | CA | LTE_CA_B2_B29_B30 |  |
| 5068 | 1700.40.1 | Core part:LTE Advanced 3 Band Carrier Aggregation (3DL/1UL) of Band 2, Band 29 and Band 30 | 327d? | 2013-06-19 A | 2014-09-12 A | 100% | 2013-06-19 | 2014-06-13 | 262d? | finish no earlier than 2014-09-12 | R4 | 2616h | 2616h | LTE_CA_B2_B29_B30-Core | 31 | AT&T | marc.grant@att.com | Rel-12 | 60 | Issam |  |  | CA | LTE_CA_B2_B29_B30-Core | RP-141084 |
| 5069 | 1700.40.2 | Perf. part:LTE Advanced 3 Band Carrier Aggregation (3DL/1UL) of Band 2, Band 29 and Band 30 | 327d? | 2013-06-19 A | 2014-09-12 A | 100% | 2013-06-19 | 2014-09-12 | 327d? | finish no earlier than 2014-09-12 | R4 | 2616h | 2616h | LTE_CA_B2_B29_B30-Perf | 31 | AT&T | marc.grant@att.com | Rel-12 | 60 | Issam |  |  | CA | LTE_CA_B2_B29_B30-Perf | RP-141084 |
| 5070 | 1700.41 | **LTE Advanced 3 Band Carrier Aggregation (3DL/1UL) of Band 4, Band 5 and Band 30** | 331d? | 2013-06-14 A | 2014-09-12 A | 100% | 2013-06-14 | 2014-09-12 | 330d? |  | R4 | 7904h | 7904h | LTE_CA_B4_B5_B30 | 31 | AT&T | marc.grant@att.com | Rel-12 | 60 | Issam |  |  | CA | LTE_CA_B4_B5_B30 |  |
| 5071 | 1700.41.1 | Core part:LTE Advanced 3 Band Carrier Aggregation (3DL/1UL) of Band 4, Band 5 and Band 30 | 330d? | 2013-06-14 A | 2014-09-12 A | 100% | 2013-06-14 | 2014-09-12 | 330d? | finish no earlier than 2014-09-12 | R4 | 2640h | 2640h | LTE_CA_B4_B5_B30-Core | 31 | AT&T | marc.grant@att.com | Rel-12 | 60 | Issam |  |  | CA | LTE_CA_B4_B5_B30-Core | RP-141084 |
| 5072 | 1700.41.2 | Perf. part:LTE Advanced 3 Band Carrier Aggregation (3DL/1UL) of Band 4, Band 5 and Band 30 | 327d? | 2013-06-19 A | 2014-09-12 A | 100% | 2013-06-19 | 2014-09-12 | 327d? | finish no earlier than 2014-09-12 | R4 | 2616h | 2616h | LTE_CA_B4_B5_B30-Perf | 31 | AT&T | marc.grant@att.com | Rel-12 | 60 | Issam |  |  | CA | LTE_CA_B4_B5_B30-Perf | RP-141084 |
| 5073 | 1700.42 | **Deleted -LTE Advanced 3 Band Carrier Aggregation (3DL/1UL) of Band 4, Band 17 and Band 30** | 127d? | 2013-06-18 A | 2013-12-06 A | 100% | 2013-06-18 | 2013-12-06 | 127d? |  | R4 | 3040h | 3040h | LTE_CA_B4_B17_B30 | 31 | AT&T | marc.grant@att.com | Rel-12 | 60 | Issam | PCG-32 | RP-62 | CA | LTE_CA_B4_B17_B30 |  |
| 5074 | 1700.42.1 | Deleted - Core part:LTE Advanced 3 Band Carrier Aggregation (3DL/1UL) of Band 4, Band 17 and Band 30 | 127d? | 2013-06-18 A | 2013-12-06 A | 100% | 2013-06-18 | 2013-12-06 | 127d? | finish no earlier than 2013-12-06 | R4 | 1016h | 1016h | LTE_CA_B4_B17_B30-Core | 31 | AT&T | marc.grant@att.com | Rel-12 | 60 | Issam | PCG-32 | RP-62 | CA | LTE_CA_B4_B17_B30-Core | RP-131598 |
| 5075 | 1700.42.2 | Deleted - Perf. part:LTE Advanced 3 Band Carrier Aggregation (3DL/1UL) of Band 4, Band 17 and Band 30 | 126d? | 2013-06-19 A | 2013-12-06 A | 100% | 2013-06-19 | 2013-12-06 | 126d? | finish no earlier than 2013-12-06 | R4 | 1008h | 1008h | LTE_CA_B4_B17_B30-Perf | 31 | AT&T | marc.grant@att.com | Rel-12 | 60 | Issam | PCG-32 | RP-62 | CA | LTE_CA_B4_B17_B30-Perf | RP-131599 |
| 5076 | 1700.43 | **LTE Advanced 3 Band Carrier Aggregation (3DL/1UL) of Band 4, Band 29 and Band 30** | 331d? | 2013-06-14 A | 2014-09-12 A | 100% | 2013-06-14 | 2014-09-12 | 330d? |  | R4 | 7904h | 7904h | LTE_CA_B4_B29_B30 | 31 | AT&T | marc.grant@att.com | Rel-12 | 60 | Issam |  |  | CA | LTE_CA_B4_B29_B30 |  |
| 5077 | 1700.43.1 | Core part:LTE Advanced 3 Band Carrier Aggregation (3DL/1UL) of Band 4, Band 29 and Band 30 | 330d? | 2013-06-14 A | 2014-09-12 A | 100% | 2013-06-14 | 2014-09-12 | 330d? | finish no earlier than 2014-09-12 | R4 | 2640h | 2640h | LTE_CA_B4_B29_B30-Core | 31 | AT&T | marc.grant@att.com | Rel-12 | 60 | Issam |  |  | CA | LTE_CA_B4_B29_B30-Core | RP-141084 |
| 5078 | 1700.43.2 | Perf. part:LTE Advanced 3 Band Carrier Aggregation (3DL/1UL) of Band 4, Band 29 and Band 30 | 327d? | 2013-06-19 A | 2014-09-12 A | 100% | 2013-06-19 | 2014-09-12 | 327d? | finish no earlier than 2014-09-12 | R4 | 2616h | 2616h | LTE_CA_B4_B29_B30-Perf | 31 | AT&T | marc.grant@att.com | Rel-12 | 60 | Issam |  |  | CA | LTE_CA_B4_B29_B30-Perf | RP-141084 |
| 5079 | 1700.44 | **LTE Advanced 3 Band Carrier Aggregation (3DL/1UL) of Band 2, Band 4 and Band 13** | 331d? | 2013-06-14 A | 2014-09-12 A | 100% | 2013-06-14 | 2014-09-12 | 330d? |  | R4 | 7904h | 7904h | LTE_CA_B2_B4_B13 | 31 | Verizon | zheng.zhao@verizonwireless.com | Rel-12 | 60 | Issam |  |  | CA | LTE_CA_B2_B4_B13 |  |
| 5080 | 1700.44.1 | Core part:LTE Advanced 3 Band Carrier Aggregation (3DL/1UL) of Band 2, Band 4 and Band 13 | 330d? | 2013-06-14 A | 2014-09-12 A | 100% | 2013-06-14 | 2014-09-12 | 330d? | finish no earlier than 2014-09-12 | R4 | 2640h | 2640h | LTE_CA_B2_B4_B13-Core | 31 | Verizon | zheng.zhao@verizonwireless.com | Rel-12 | 60 | Issam |  |  | CA | LTE_CA_B2_B4_B13-Core | RP-141084 |
| 5081 | 1700.44.2 | Perf. part:LTE Advanced 3 Band Carrier Aggregation (3DL/1UL) of Band 2, Band 4 and Band 13 | 327d? | 2013-06-19 A | 2014-09-12 A | 100% | 2013-06-19 | 2014-09-12 | 327d? | finish no earlier than 2014-09-12 | R4 | 2616h | 2616h | LTE_CA_B2_B4_B13-Perf | 31 | Verizon | zheng.zhao@verizonwireless.com | Rel-12 | 60 | Issam |  |  | CA | LTE_CA_B2_B4_B13-Perf | RP-141084 |
| 5082 | 1700.45 | **LTE Advanced 3 Band Carrier Aggregation (3DL/1UL) of Band 2, Band 2 and Band 13** | 329d? | 2013-06-18 A | 2014-09-12 A | 100% | 2013-06-18 | 2014-09-12 | 328d? |  | R4 | 7864h | 7864h | LTE_CA_B2_B2_B13 | 31 | Verizon | zheng.zhao@verizonwireless.com | Rel-12 | 60 | Issam |  |  | CA | LTE_CA_B2_B2_B13 |  |
| 5083 | 1700.45.1 | Core part:LTE Advanced 3 Band Carrier Aggregation (3DL/1UL) of Band 2, Band 2 and Band 13 | 327d? | 2013-06-18 A | 2014-09-12 A | 100% | 2013-06-18 | 2014-09-12 | 327d? | finish no earlier than 2014-09-12 | R4 | 2616h | 2616h | LTE_CA_B2_B2_B13-Core | 31 | Verizon | zheng.zhao@verizonwireless.com | Rel-12 | 60 | Issam |  |  | CA | LTE_CA_B2_B2_B13-Core | RP-141084 |
| 5084 | 1700.45.2 | Perf. part:LTE Advanced 3 Band Carrier Aggregation (3DL/1UL) of Band 2, Band 2 and Band 13 | 327d? | 2013-06-19 A | 2014-09-12 A | 100% | 2013-06-19 | 2014-09-12 | 327d? | finish no earlier than 2014-09-12 | R4 | 2616h | 2616h | LTE_CA_B2_B2_B13-Perf | 31 | Verizon | zheng.zhao@verizonwireless.com | Rel-12 | 60 | Issam |  |  | CA | LTE_CA_B2_B2_B13-Perf | RP-141084 |
| 5085 | 1700.46 | **LTE Advanced 3 Band Carrier Aggregation (3DL/1UL) of Band 4, Band 4 and Band 13** | 331d? | 2013-06-14 A | 2014-09-12 A | 100% | 2013-06-14 | 2014-09-12 | 330d? |  | R4 | 7928h | 7928h | LTE_CA_B4_B4_B13 | 31 | Verizon | zheng.zhao@verizonwireless.com | Rel-12 | 60 | Issam |  |  | CA | LTE_CA_B4_B4_B13 |  |
| 5086 | 1700.46.1 | Core part:LTE Advanced 3 Band Carrier Aggregation (3DL/1UL) of Band 4, Band 4 and Band 13 | 330d? | 2013-06-14 A | 2014-09-12 A | 100% | 2013-06-14 | 2014-09-12 | 330d? | finish no earlier than 2014-09-12 | R4 | 2640h | 2640h | LTE_CA_B4_B4_B13-Core | 31 | Verizon | zheng.zhao@verizonwireless.com | Rel-12 | 60 | Issam |  |  | CA | LTE_CA_B4_B4_B13-Core | RP-141084 |
| 5087 | 1700.46.2 | Perf. part:LTE Advanced 3 Band Carrier Aggregation (3DL/1UL) of Band 4, Band 4 and Band 13 | 330d? | 2013-06-14 A | 2014-09-12 A | 100% | 2013-06-14 | 2014-09-12 | 330d? | finish no earlier than 2014-09-12 | R4 | 2640h | 2640h | LTE_CA_B4_B4_B13-Perf | 31 | Verizon | zheng.zhao@verizonwireless.com | Rel-12 | 60 | Issam |  |  | CA | LTE_CA_B4_B4_B13-Perf | RP-141084 |

Notes:
- 5064: Inter-band 3DL / Impacted TSs and TRs: LTE
- 5065: RP#62 stopped (25% complete) following RP-131652 discussion / Impacted TSs and TRs: 36.101; 36.104; 36.133; 36.141; 36.307; new generic 36.853 (3 Band CA with 1UL)
- 5066: RP#62 stopped (25% complete) following RP-131652 discussion / Impacted TSs and TRs: 36.101; 36.104; 36.133; 36.141; 36.307
- 5067: Inter-band 3DL / Impacted TSs and TRs: LTE
- 5068: RP#65 completed. Updated WID RP-131697=>RP-141212 / Impacted TSs and TRs: 36.101; 36.104; 36.133; 36.141; 36.307; new generic 36.853 (3 Band CA with 1UL)
- 5069: RP#65 completed / Impacted TSs and TRs: 36.101; 36.104; 36.133; 36.141; 36.307
- 5070: Inter-band CA 3DL / Impacted TSs and TRs: LTE
- 5071: RP#65 completed. Updated WID RP-131698=>RP-141213 / Impacted TSs and TRs: 36.101; 36.104; 36.133; 36.141; 36.307; new generic 36.853 (3 Band CA with 1UL)
- 5072: RP#65 completed / Impacted TSs and TRs: 36.101; 36.104; 36.133; 36.141; 36.307
- 5073: Inter-band 3DL / Impacted TSs and TRs: LTE
- 5074: RP#62 stopped (25% complete) following RP-131653 discussion / Impacted TSs and TRs: 36.101; 36.104; 36.133; 36.141; 36.307; new generic 36.853 (3 Band CA with 1UL)
- 5075: RP#62 stopped (25% complete) following RP-131653 discussion / Impacted TSs and TRs: 36.101; 36.104; 36.133; 36.141; 36.307
- 5076: Inter-band CA 3DL / Impacted TSs and TRs: LTE
- 5077: RP#65 completed. Updated WID RP-131699=>RP- 141215 / Impacted TSs and TRs: 36.101; 36.104; 36.133; 36.141; 36.307; new generic 36.853 (3 Band CA with 1UL)
- 5078: RP#65 completed / Impacted TSs and TRs: 36.101; 36.104; 36.133; 36.141; 36.307
- 5079: Inter-band CA 3DL / Impacted TSs and TRs: LTE
- 5080: RP#65 completed. Updated RP-131684=>RP-141434 / Impacted TSs and TRs: 36.101; 36.104; 36.133; new generic 36.853 (3 Band CA with 1UL)
- 5081: RP#65 completed / Impacted TSs and TRs: 36.101; 36.133; 36.141; 36.307
- 5082: Inter-band CA 3DL / Impacted TSs and TRs: LTE
- 5083: RP#65 completed. Updated WID RP-131682=>RP-141435 / Impacted TSs and TRs: 36.101; 36.104; 36.133; new generic 36.853 (3 Band CA with 1UL)
- 5084: RP#65 completed / Impacted TSs and TRs: 36.101; 36.133; 36.141; 36.307
- 5085: Inter-band CA 3DL / Impacted TSs and TRs: LTE
- 5086: RP#65 completed. Updated WID RP-131683=>RP-141433 / Impacted TSs and TRs: 36.101; 36.104; 36.133; new generic 36.853 (3 Band CA with 1UL)
- 5087: RP#65 completed / Impacted TSs and TRs: 36.101; 36.133; 36.141; 36.307

| ID | WBS | Task | Duration | Start | Finish | Complete | Baseline start | Baseline finish | Baseline duration | Constraint | Resources | Work | Actual work | Acronym | PCG approved | Impacted TSs and TRs | WI rapporteur name | WI rapporteur e-mail | Release | TSG approved | MCC resp | Special Focus Doc | Acronym_3GU_Export | Status Report |
| --- | --- | --- | --- | --- | --- | --- | --- | --- | --- | --- | --- | --- | --- | --- | --- | --- | --- | --- | --- | --- | --- | --- | --- | --- |
| 5088 | 1700.47 | **LTE Advanced inter-band Carrier Aggregation of Band 7 and Band 28** | 66d? | 2013-09-09 A | 2013-12-06 A | 100% | 2013-09-09 | 2013-12-06 | 66d? |  | R4 | 1584h | 1584h | LTE_CA_B7_B28 | 31 | LTE | Huawei | Liehai Liu (liuliehai@huawei.com) | Rel-12 | 61 | Issam | CA | LTE_CA_B7_B28 |  |
| 5089 | 1700.47.1 | Core part:LTE Advanced inter-band Carrier Aggregation of Band 7 and Band 28 | 66d? | 2013-09-09 A | 2013-12-06 A | 100% | 2013-09-09 | 2013-12-06 | 66d? | finish no earlier than 2013-12-06 | R4 | 528h | 528h | LTE_CA_B7_B28-Core | 31 | 36.101; 36.104; 36.307 | Huawei | Liehai Liu (liuliehai@huawei.com) | Rel-12 | 61 | Issam | CA | LTE_CA_B7_B28-Core | RP-131545 |
| 5090 | 1700.47.2 | Perf. part:LTE Advanced inter-band Carrier Aggregation of Band 7 and Band 28 | 66d? | 2013-09-09 A | 2013-12-06 A | 100% | 2013-09-09 | 2013-12-06 | 66d? | finish no earlier than 2013-12-06 | R4 | 528h | 528h | LTE_CA_B7_B28-Perf | 31 | 36.141 | Huawei | Liehai Liu (liuliehai@huawei.com) | Rel-12 | 61 | Issam | CA | LTE_CA_B7_B28-Perf | RP-131546 |
| 5091 | 1700.48 | **LTE Advanced inter-band Carrier Aggregation of Band 5 and Band 25** | 66d? | 2013-09-09 A | 2013-12-06 A | 100% | 2013-09-09 | 2013-12-06 | 66d? |  | R4 | 1584h | 1584h | LTE_CA_B5_B25 | 31 | LTE | U.S. Cellular | sebastian.thalanany@uscellular.com | Rel-12 | 61 | Issam | CA | LTE_CA_B5_B25 |  |
| 5092 | 1700.48.1 | Core part:LTE Advanced inter-band Carrier Aggregation of Band 5 and Band 25 | 66d? | 2013-09-09 A | 2013-12-06 A | 100% | 2013-09-09 | 2013-12-06 | 66d? | finish no earlier than 2013-12-06 | R4 | 528h | 528h | LTE_CA_B5_B25-Core | 31 | 36.101; 36.104; 36.133; new generic 36.851 | U.S. Cellular | sebastian.thalanany@uscellular.com | Rel-12 | 61 | Issam | CA | LTE_CA_B5_B25-Core | RP-131543 |
| 5093 | 1700.48.2 | Perf. part:LTE Advanced inter-band Carrier Aggregation of Band 5 and Band 25 | 66d? | 2013-09-09 A | 2013-12-06 A | 100% | 2013-09-09 | 2013-12-06 | 66d? | finish no earlier than 2013-12-06 | R4 | 528h | 528h | LTE_CA_B5_B25-Perf | 31 | 36.141; 36.307 | U.S. Cellular | sebastian.thalanany@uscellular.com | Rel-12 | 61 | Issam | CA | LTE_CA_B5_B25-Perf | RP-131705 |
| 5094 | 1700.49 | **LTE Advanced inter-band Carrier Aggregation of Band 1 and Band 11** | 202d? | 2013-09-09 A | 2014-06-13 A | 100% | 2013-09-09 | 2014-06-13 | 202d? |  | R4 | 4848h | 4848h | LTE_CA_B1_B11 | 31 | LTE | SoftBank Mobile | kenichi.kihara@g.softbank.co.jp | Rel-12 | 61 | Issam | CA | LTE_CA_B1_B11 |  |
| 5095 | 1700.49.1 | Core part:LTE Advanced inter-band Carrier Aggregation of Band 1 and Band 11 | 202d? | 2013-09-09 A | 2014-06-13 A | 100% | 2013-09-09 | 2014-06-13 | 202d? | finish no earlier than 2014-06-13 | R4 | 1616h | 1616h | LTE_CA_B1_B11-Core | 31 | 36.101; 36.104; new generic 36.851 | SoftBank Mobile | kenichi.kihara@g.softbank.co.jp | Rel-12 | 61 | Issam | CA | LTE_CA_B1_B11-Core | RP-140569 |
| 5096 | 1700.49.2 | Perf. part:LTE Advanced inter-band Carrier Aggregation of Band 1 and Band 11 | 202d? | 2013-09-09 A | 2014-06-13 A | 100% | 2013-09-09 | 2014-06-13 | 202d? | finish no earlier than 2014-06-13 | R4 | 1616h | 1616h | LTE_CA_B1_B11-Perf | 31 | 36.141; 36.307 | SoftBank Mobile | kenichi.kihara@g.softbank.co.jp | Rel-12 | 61 | Issam | CA | LTE_CA_B1_B11-Perf | RP-140569 |
| 5097 | 1700.50 | **LTE Advanced inter-band Carrier Aggregation of Band 8 and Band 11** | 268d? | 2013-09-09 A | 2014-09-12 A | 100% | 2013-09-09 | 2014-09-12 | 267d? |  | R4 | 6416h | 6416h | LTE_CA_B8_B11 | 31 | LTE | SoftBank Mobile | kenichi.kihara@g.softbank.co.jp | Rel-12 | 61 | Issam | CA | LTE_CA_B8_B11 |  |
| 5098 | 1700.50.1 | Core part:LTE Advanced inter-band Carrier Aggregation of Band 8 and Band 11 | 267d? | 2013-09-09 A | 2014-09-12 A | 100% | 2013-09-09 | 2014-09-12 | 267d? | finish no earlier than 2014-09-12 | R4 | 2136h | 2136h | LTE_CA_B8_B11-Core | 31 | 36.101; 36.104; new generic 36.851 | SoftBank Mobile | kenichi.kihara@g.softbank.co.jp | Rel-12 | 61 | Issam | CA | LTE_CA_B8_B11-Core | RP-141084 |
| 5099 | 1700.50.2 | Perf. part:LTE Advanced inter-band Carrier Aggregation of Band 8 and Band 11 | 267d? | 2013-09-09 A | 2014-09-12 A | 100% | 2013-09-09 | 2014-09-12 | 267d? | finish no earlier than 2014-09-12 | R4 | 2136h | 2136h | LTE_CA_B8_B11-Perf | 31 | 36.141; 36.307 | SoftBank Mobile | kenichi.kihara@g.softbank.co.jp | Rel-12 | 61 | Issam | CA | LTE_CA_B8_B11-Perf | RP-141084 |
| 5100 | 1700.51 | **LTE Advanced inter-band Carrier Aggregation of Band 5 and Band 7** | 62d? | 2013-09-09 A | 2013-12-02 A | 100% | 2013-09-09 | 2013-12-02 | 62d? |  | R4 | 1488h | 1488h | LTE_CA_B5_B7 | 31 | LTE | LG Uplus | Yeonsang KOO (yskoo@lguplus.co.kr) | Rel-12 | 61 | Issam | CA | LTE_CA_B5_B7 |  |
| 5101 | 1700.51.1 | Core part:LTE Advanced inter-band Carrier Aggregation of Band 5 and Band 7 | 62d? | 2013-09-09 A | 2013-12-02 A | 100% | 2013-09-09 | 2013-12-02 | 62d? | finish no earlier than 2013-12-02 | R4 | 496h | 496h | LTE_CA_B5_B7-Core | 31 | 36.101; 36.104; 36.133; new generic 36.851 | LG Uplus | Yeonsang KOO (yskoo@lguplus.co.kr) | Rel-12 | 61 | Issam | CA | LTE_CA_B5_B7-Core | RP-131541 |
| 5102 | 1700.51.2 | Perf. part:LTE Advanced inter-band Carrier Aggregation of Band 5 and Band 7 | 62d? | 2013-09-09 A | 2013-12-02 A | 100% | 2013-09-09 | 2013-12-02 | 62d? | finish no earlier than 2013-12-02 | R4 | 496h | 496h | LTE_CA_B5_B7-Perf | 31 | 36.141; 36.307 | LG Uplus | Yeonsang KOO (yskoo@lguplus.co.kr) | Rel-12 | 61 | Issam | CA | LTE_CA_B5_B7-Perf | RP-131542 |
| 5103 | 1700.52 | **LTE Advanced intra-band contiguous Carrier Aggregation in Band 41 for 3DL** | 400d? | 2013-09-09 A | 2015-03-13 A | 100% | 2013-09-09 | 2014-09-12 | 267d? |  | R4 | 8512h | 8512h | LTE_CA_C_B41_3DL | 31 | LTE | Alcatel-Lucent | man-hung.ng@alcatel-lucent.com | Rel-12 | 61 | Issam | CA | LTE_CA_C_B41_3DL |  |
| 5104 | 1700.52.1 | Core part: LTE Advanced intra-band contiguous Carrier Aggregation in Band 41 for 3DL | 267d? | 2013-09-09 A | 2014-09-12 A | 100% | 2013-09-09 | 2014-09-12 | 267d? | finish no earlier than 2014-09-12 | R4 | 2136h | 2136h | LTE_CA_C_B41_3DL-Core | 31 | 36.101; 36.104; 36.133; 36.307; New 36.833-5-41 | Alcatel-Lucent | man-hung.ng@alcatel-lucent.com | Rel-12 | 61 | Issam | CA | LTE_CA_C_B41_3DL-Core | RP-141084 |
| 5105 | 1700.52.2 | Perf. part: LTE Advanced intra-band contiguous Carrier Aggregation in Band 41 for 3DL | 397d? | 2013-09-09 A | 2015-03-13 A | 100% | 2013-09-09 | 2014-09-12 | 267d? | finish no earlier than 2015-03-15 | R4 | 3176h | 3176h | LTE_CA_C_B41_3DL-Perf | 31 | 36.141 | Alcatel-Lucent | man-hung.ng@alcatel-lucent.com | Rel-12 | 61 | Issam | CA | LTE_CA_C_B41_3DL-Perf | RP-150013 |
| 5106 | 1700.53 | **LTE Advanced intra-band non-contiguous Carrier Aggregation in Band 2** | 202d? | 2013-09-09 A | 2014-06-13 A | 100% | 2013-09-09 | 2014-06-13 | 202d? |  | R4 | 4840h | 4840h | LTE_CA_NC_B2 | 31 | LTE | Ericsson | imadur.rahman@ericsson.com | Rel-12 | 61 | Issam | CA | LTE_CA_NC_B2 |  |
| 5107 | 1700.53.1 | Core part:LTE Advanced intra-band non-contiguous Carrier Aggregation in Band 2 | 202d? | 2013-09-09 A | 2014-06-13 A | 100% | 2013-09-09 | 2014-06-13 | 202d? | finish no earlier than 2014-06-13 | R4 | 1616h | 1616h | LTE_CA_NC_B2-Core | 31 | 36.101; 36.104; 36.133; New 36.833-2-02 | Ericsson | imadur.rahman@ericsson.com | Rel-12 | 61 | Issam | CA | LTE_CA_NC_B2-Core | RP-140569 |
| 5108 | 1700.53.2 | Perf. part:LTE Advanced intra-band non-contiguous Carrier Aggregation in Band 2 | 201d? | 2013-09-10 A | 2014-06-13 A | 100% | 2013-09-10 | 2014-06-13 | 201d? | finish no earlier than 2014-06-13 | R4 | 1608h | 1608h | LTE_CA_NC_B2-Perf | 31 | 36.141; 36.307 | Ericsson | imadur.rahman@ericsson.com | Rel-12 | 61 | Issam | CA | LTE_CA_NC_B2-Perf | RP-140569 |
| 5109 | 1700.54 | **LTE Advanced inter-band Carrier Aggregation of Band 1 and Band 3** | 202d? | 2013-12-09 A | 2014-09-12 A | 100% | 2013-12-09 | 2014-09-12 | 201d? |  | R4 | 4832h | 4832h | LTE_CA_B1_B3 | 32 | LTE | China Unicom | Hao Chen (chenhao49@chinaunicom.cn) | Rel-12 | 62 | Issam | CA | LTE_CA_B1_B3 |  |
| 5110 | 1700.54.1 | Core part:LTE Advanced inter-band Carrier Aggregation of Band 1 and Band 3 | 201d? | 2013-12-09 A | 2014-09-12 A | 100% | 2013-12-09 | 2014-09-12 | 201d? | finish no earlier than 2014-09-12 | R4 | 1608h | 1608h | LTE_CA_B1_B3-Core | 32 | 36.101; 36.104; 36.133; new generic 36.851 | China Unicom | Hao Chen (chenhao49@chinaunicom.cn) | Rel-12 | 62 | Issam | CA | LTE_CA_B1_B3-Core | RP-141084 |
| 5111 | 1700.54.2 | Perf. part:LTE Advanced inter-band Carrier Aggregation of Band 1 and Band 3 | 201d? | 2013-12-09 A | 2014-09-12 A | 100% | 2013-12-09 | 2014-09-12 | 201d? | finish no earlier than 2014-09-12 | R4 | 1608h | 1608h | LTE_CA_B1_B3-Perf | 32 | 36.141; 36.307 | China Unicom | Hao Chen (chenhao49@chinaunicom.cn) | Rel-12 | 62 | Issam | CA | LTE_CA_B1_B3-Perf | RP-141084 |

Notes:
- 5088: Inter-band 1UL/2DL
- 5089: RP#62 completed
- 5090: RP#62 completed
- 5091: Inter-band 1UL/2DL
- 5092: RP#62 completed
- 5093: RP#62 completed
- 5094: Inter-band CA 2DL
- 5095: RP#64 completed
- 5096: RP#64 completed
- 5097: Inter-band CA 2DL
- 5098: RP#65 completed
- 5099: RP#65 completed
- 5100: Inter-band 1UL/2DL
- 5101: RP#62 completed
- 5102: RP#62 completed
- 5103: Intra-band contig. CA 3DL
- 5104: RP#65 completed
- 5105: ¦WID: RP-142043->RP-142017¦Stat Rep: RP-141084->RP-141732 1st Apr 15: Compl:70%->100% 1st Apr 15: Stat Rep: RP-141732->RP-150013
- 5106: Intra-band non-contig. CA 2DL
- 5107: RP#64 completed. TR 36.833-2-02v100 for 1-step Approval
- 5108: RP#64 completed
- 5109: Inter-band CA 2DL
- 5110: RP#65 completed
- 5111: RP#65 completed

| ID | WBS | Task | Duration | Start | Finish | Complete | Baseline start | Baseline finish | Baseline duration | Constraint | Resources | Work | Actual work | Acronym | PCG approved | WI rapporteur name | WI rapporteur e-mail | Release | TSG approved | MCC resp | Special Focus Doc | Acronym_3GU_Export | Status Report |
| --- | --- | --- | --- | --- | --- | --- | --- | --- | --- | --- | --- | --- | --- | --- | --- | --- | --- | --- | --- | --- | --- | --- | --- |
| 5112 | 1700.55 | **LTE Advanced inter-band Carrier Aggregation of Band 1 and Band 28** | 270d? | 2013-12-09 A | 2014-12-15 A | 100% | 2013-12-09 | 2014-09-12 | 201d? |  | R4 | 6432h | 6432h | LTE_CA_B1_B28 | 32 | KDDI | Masaaki Obara (ms-obara@kddi.com) | Rel-12 | 62 | Issam | CA | LTE_CA_B1_B28 |  |
| 5113 | 1700.55.1 | Core part:LTE Advanced inter-band Carrier Aggregation of Band 1 and Band 28 | 267d? | 2013-12-09 A | 2014-12-15 A | 100% | 2013-12-09 | 2014-09-12 | 201d? | finish no earlier than 2014-12-15 | R4 | 2136h | 2136h | LTE_CA_B1_B28-Core | 32 | KDDI | Masaaki Obara (ms-obara@kddi.com) | Rel-12 | 62 | Issam | CA | LTE_CA_B1_B28-Core | RP-141732 |
| 5114 | 1700.55.2 | Perf. part:LTE Advanced inter-band Carrier Aggregation of Band 1 and Band 28 | 267d? | 2013-12-12 A | 2014-12-15 A | 100% | 2013-12-09 | 2014-09-12 | 201d? | finish no earlier than 2014-12-15 | R4 | 2136h | 2136h | LTE_CA_B1_B28-Perf | 32 | KDDI | Masaaki Obara (ms-obara@kddi.com) | Rel-12 | 62 | Issam | CA | LTE_CA_B1_B28-Perf | RP-141732 |
| 5115 | 1700.56 | **LTE Advanced inter-band Carrier Aggregation of Band 2 and Band 4 - Additional bandwidth combination set** | 65d? | 2013-12-09 A | 2014-03-06 A | 100% | 2013-12-09 | 2014-03-06 | 65d? |  | R4 | 1560h | 1560h | LTE_CA_B2_B4_BWset | 32 | T-Mobile USA | nelson.ueng@t-mobile.com | Rel-12 | 62 | Issam | CA | LTE_CA_B2_B4_BWset |  |
| 5116 | 1700.56.1 | Core part:LTE Advanced inter-band Carrier Aggregation of Band 2 and Band 4 - Additional bandwidth combination set | 65d? | 2013-12-09 A | 2014-03-06 A | 100% | 2013-12-09 | 2014-03-06 | 65d? | finish no earlier than 2014-03-06 | R4 | 520h | 520h | LTE_CA_B2_B4_BWset-Core | 32 | T-Mobile USA | nelson.ueng@t-mobile.com | Rel-12 | 62 | Issam | CA | LTE_CA_B2_B4_BWset-Core | RP-140428 |
| 5117 | 1700.56.2 | Perf. part:LTE Advanced inter-band Carrier Aggregation of Band 2 and Band 4 - Additional bandwidth combination set | 65d? | 2013-12-09 A | 2014-03-06 A | 100% | 2013-12-09 | 2014-03-06 | 65d? | finish no earlier than 2014-03-06 | R4 | 520h | 520h | LTE_CA_B2_B4_BWset-Perf | 32 | T-Mobile USA | nelson.ueng@t-mobile.com | Rel-12 | 62 | Issam | CA | LTE_CA_B2_B4_BWset-Perf | RP-140428 |
| 5118 | 1700.57 | **LTE Advanced inter-band Carrier Aggregation of Band 4 and Band 27** | 136d? | 2013-12-09 A | 2014-06-13 A | 100% | 2013-12-09 | 2014-06-13 | 136d? |  | R4 | 3264h | 3264h | LTE_CA_B4_B27 | 32 | NII Holdings | bill.shvodian@nii.com | Rel-12 | 62 | Issam | CA | LTE_CA_B4_B27 |  |
| 5119 | 1700.57.1 | Core part:LTE Advanced inter-band Carrier Aggregation of Band 4 and Band 27 | 136d? | 2013-12-09 A | 2014-06-13 A | 100% | 2013-12-09 | 2014-06-13 | 136d? | finish no earlier than 2014-06-13 | R4 | 1088h | 1088h | LTE_CA_B4_B27-Core | 32 | NII Holdings | bill.shvodian@nii.com | Rel-12 | 62 | Issam | CA | LTE_CA_B4_B27-Core | RP-140569 |
| 5120 | 1700.57.2 | Perf. part:LTE Advanced inter-band Carrier Aggregation of Band 4 and Band 27 | 136d? | 2013-12-09 A | 2014-06-13 A | 100% | 2013-12-09 | 2014-06-13 | 136d? | finish no earlier than 2014-06-13 | R4 | 1088h | 1088h | LTE_CA_B4_B27-Perf | 32 | NII Holdings | bill.shvodian@nii.com | Rel-12 | 62 | Issam | CA | LTE_CA_B4_B27-Perf | RP-140569 |
| 5121 | 1700.58 | **LTE Advanced inter-band Carrier Aggregation of Band 3 and Band 27** | 65d? | 2013-12-09 A | 2014-03-06 A | 100% | 2013-12-09 | 2014-03-06 | 65d? |  | R4 | 1560h | 1560h | LTE_CA_B3_B27 | 32 | KT | Chungwoo HWANG (cwhwang@kt.com) | Rel-12 | 62 | Issam | CA | LTE_CA_B3_B27 | RP-140428 |
| 5122 | 1700.58.1 | Core part:LTE Advanced inter-band Carrier Aggregation of Band 3 and Band 27 | 65d? | 2013-12-09 A | 2014-03-06 A | 100% | 2013-12-09 | 2014-03-06 | 65d? | finish no earlier than 2014-03-06 | R4 | 520h | 520h | LTE_CA_B3_B27-Core | 32 | KT | Chungwoo HWANG (cwhwang@kt.com) | Rel-12 | 62 | Issam | CA | LTE_CA_B3_B27-Core | RP-140428 |
| 5123 | 1700.58.2 | Perf. part:LTE Advanced inter-band Carrier Aggregation of Band 3 and Band 27 | 65d? | 2013-12-09 A | 2014-03-06 A | 100% | 2013-12-09 | 2014-03-06 | 65d? | finish no earlier than 2014-03-06 | R4 | 520h | 520h | LTE_CA_B3_B27-Perf | 32 | KT | Chungwoo HWANG (cwhwang@kt.com) | Rel-12 | 62 | Issam | CA | LTE_CA_B3_B27-Perf | RP-140428 |
| 5124 | 1700.59 | **LTE Advanced inter-band Carrier Aggregation in Band 8 and Band 20 - Additional channel bandwidth** | 65d? | 2013-12-09 A | 2014-03-06 A | 100% | 2013-12-09 | 2014-03-06 | 65d? |  | R4 | 1560h | 1560h | LTE_CA_B8_B20_BW | 32 | Vodafone | luis.anaya@vodafone.com | Rel-12 | 62 | Issam | CA | LTE_CA_B8_B20_BW | RP-140428 |
| 5125 | 1700.59.1 | Core part:LTE Advanced inter-band Carrier Aggregation in Band 8 and Band 20 - Additional channel bandwidth | 65d? | 2013-12-09 A | 2014-03-06 A | 100% | 2013-12-09 | 2014-03-06 | 65d? | finish no earlier than 2014-03-06 | R4 | 520h | 520h | LTE_CA_B8_B20_BW-Core | 32 | Vodafone | luis.anaya@vodafone.com | Rel-12 | 62 | Issam | CA | LTE_CA_B8_B20_BW-Core | RP-140428 |
| 5126 | 1700.59.2 | Perf. part:LTE Advanced inter-band Carrier Aggregation in Band 8 and Band 20 - Additional channel bandwidth | 65d? | 2013-12-09 A | 2014-03-06 A | 100% | 2013-12-09 | 2014-03-06 | 65d? | finish no earlier than 2014-03-06 | R4 | 520h | 520h | LTE_CA_B8_B20_BW-Perf | 32 | Vodafone | luis.anaya@vodafone.com | Rel-12 | 62 | Issam | CA | LTE_CA_B8_B20_BW-Perf | RP-140428 |
| 5127 | 1700.60 | **LTE Advanced 3 Band Carrier Aggregation (3DL/1UL) for Band 1, Band 3 and Band 8** | 202d? | 2013-12-09 A | 2014-09-12 A | 100% | 2013-12-09 | 2014-09-12 | 201d? |  | R4 | 4832h | 4832h | LTE_CA_B1_B3_B8 | 32 | KT | Ilwhan Kim (ilwhan.kim@kt.com) | Rel-12 | 62 | Issam | CA | LTE_CA_B1_B3_B8 |  |
| 5128 | 1700.60.1 | Core part:LTE Advanced 3 Band Carrier Aggregation (3DL/1UL) for Band 1, Band 3 and Band 8 | 201d? | 2013-12-09 A | 2014-09-12 A | 100% | 2013-12-09 | 2014-09-12 | 201d? | finish no earlier than 2014-09-12 | R4 | 1608h | 1608h | LTE_CA_B1_B3_B8-Core | 32 | KT | Ilwhan Kim (ilwhan.kim@kt.com) | Rel-12 | 62 | Issam | CA | LTE_CA_B1_B3_B8-Core | RP-141084 |
| 5129 | 1700.60.2 | Perf. part:LTE Advanced 3 Band Carrier Aggregation (3DL/1UL) for Band 1, Band 3 and Band 8 | 201d? | 2013-12-09 A | 2014-09-12 A | 100% | 2013-12-09 | 2014-09-12 | 201d? | finish no earlier than 2014-09-12 | R4 | 1608h | 1608h | LTE_CA_B1_B3_B8-Perf | 32 | KT | Ilwhan Kim (ilwhan.kim@kt.com) | Rel-12 | 62 | Issam | CA | LTE_CA_B1_B3_B8-Perf | RP-141084 |
| 5130 | 1700.61 | **LTE Advanced 3 Band Carrier Aggregation (3DL/1UL) for Band 1, Band 5 and Band 7** | 202d? | 2013-12-09 A | 2014-09-12 A | 100% | 2013-12-09 | 2014-09-12 | 201d? |  | R4 | 4832h | 4832h | LTE_CA_B1_B5_B7 | 32 | LG Uplus | Yeonsang KOO (yskoo@lguplus.co.kr) | Rel-12 | 62 | Issam | CA | LTE_CA_B1_B5_B7 |  |
| 5131 | 1700.61.1 | Core part:LTE Advanced 3 Band Carrier Aggregation (3DL/1UL) for Band 1, Band 5 and Band 7 | 201d? | 2013-12-09 A | 2014-09-12 A | 100% | 2013-12-09 | 2014-09-12 | 201d? | finish no earlier than 2014-09-12 | R4 | 1608h | 1608h | LTE_CA_B1_B5_B7-Core | 32 | LG Uplus | Yeonsang KOO (yskoo@lguplus.co.kr) | Rel-12 | 62 | Issam | CA | LTE_CA_B1_B5_B7-Core | RP-141084 |
| 5132 | 1700.61.2 | Perf. part:LTE Advanced 3 Band Carrier Aggregation (3DL/1UL) for Band 1, Band 5 and Band 7 | 201d? | 2013-12-09 A | 2014-09-12 A | 100% | 2013-12-09 | 2014-09-12 | 201d? | finish no earlier than 2014-09-12 | R4 | 1608h | 1608h | LTE_CA_B1_B5_B7-Perf | 32 | LG Uplus | Yeonsang KOO (yskoo@lguplus.co.kr) | Rel-12 | 62 | Issam | CA | LTE_CA_B1_B5_B7-Perf | RP-141084 |
| 5133 | 1700.62 | **LTE Advanced 3 Band Carrier Aggregation (3DL/1UL) for Band 2, Band 4 and Band 5** | 202d? | 2013-12-09 A | 2014-09-12 A | 100% | 2013-12-09 | 2014-09-12 | 201d? |  | R4 | 4832h | 4832h | LTE_CA_B2_B4_B5 | 32 | U.S. Cellular | sebastian.thalanany@uscellular.com | Rel-12 | 62 | Issam | CA | LTE_CA_B2_B4_B5 |  |
| 5134 | 1700.62.1 | Core part:LTE Advanced 3 Band Carrier Aggregation (3DL/1UL) for Band 2, Band 4 and Band 5 | 201d? | 2013-12-09 A | 2014-09-12 A | 100% | 2013-12-09 | 2014-09-12 | 201d? | finish no earlier than 2014-09-12 | R4 | 1608h | 1608h | LTE_CA_B2_B4_B5-Core | 32 | U.S. Cellular | sebastian.thalanany@uscellular.com | Rel-12 | 62 | Issam | CA | LTE_CA_B2_B4_B5-Core | RP-141084 |
| 5135 | 1700.62.2 | Perf. part:LTE Advanced 3 Band Carrier Aggregation (3DL/1UL) for Band 2, Band 4 and Band 5 | 201d? | 2013-12-09 A | 2014-09-12 A | 100% | 2013-12-09 | 2014-09-12 | 201d? | finish no earlier than 2014-09-12 | R4 | 1608h | 1608h | LTE_CA_B2_B4_B5-Perf | 32 | U.S. Cellular | sebastian.thalanany@uscellular.com | Rel-12 | 62 | Issam | CA | LTE_CA_B2_B4_B5-Perf | RP-141084 |

Notes:
- 5112: Inter-band CA 2DL / Impacted TSs and TRs: LTE
- 5113: ¦WID: RP-142043->RP-141803¦Stat Rep: RP-141084->RP-141732 / Impacted TSs and TRs: 36.101; 36.104; 36.133; 36.307; new generic 36.851
- 5114: ¦WID: RP-142043->RP-141803¦Stat Rep: RP-141084->RP-141732 / Impacted TSs and TRs: 36.133; 36.141
- 5115: Inter-band 2DL / Impacted TSs and TRs: LTE
- 5116: RP#63 completed / Impacted TSs and TRs: 36.101; new generic 36.851
- 5117: RP#63 completed / Impacted TSs and TRs: 36.307
- 5118: Inter-band CA 2DL / Impacted TSs and TRs: LTE
- 5119: RP#64 completed / Impacted TSs and TRs: 36.101; 36.104; 36.133; new generic 36.851
- 5120: RP#64 completed / Impacted TSs and TRs: 36.141; 36.307
- 5121: Inter-band CA 2DL/1UL / Impacted TSs and TRs: LTE
- 5122: RP#63 completed. Updated WID RP-131752=>RP-140119 / Impacted TSs and TRs: 36.101; 36.104; 36.133; 36.307; New generic 36.851
- 5123: RP#63 completed. Updated WID RP-131752=>RP-140119 / Impacted TSs and TRs: 36.101; 36.104; 36.133; 36.141
- 5124: Inter-band 2DL / Impacted TSs and TRs: LTE
- 5125: RP#63 completed / Impacted TSs and TRs: 36.101; 36.104; 36.307
- 5126: RP#63 completed / Impacted TSs and TRs: 36.141
- 5127: Inter-band CA 3DL / Impacted TSs and TRs: LTE
- 5128: RP#65 completed. Updated WID RP-131753=>RP-141654 / Impacted TSs and TRs: 36.101; 36.104; 36.133; 36.141; 36.307; new generic 36.853 (3 Band CA with 1UL)
- 5129: RP#65 completed / Impacted TSs and TRs: 36.101; 36.104; 36.133; 36.141; 36.307
- 5130: Inter-band CA 3DL / Impacted TSs and TRs: LTE
- 5131: RP#65 completed. Updated WID RP-140209=>RP-141462 / Impacted TSs and TRs: 36.101; 36.104; 36.133; new generic 36.853 (3 Band CA with 1UL)
- 5132: RP#65 completed / Impacted TSs and TRs: 36.141; 36.307
- 5133: Inter-band CA 3DL / Impacted TSs and TRs: LTE
- 5134: RP#65 completed / Impacted TSs and TRs: 36.101; 36.104; 36.133; new generic 36.853 (3 Band CA with 1UL)
- 5135: RP#65 completed / Impacted TSs and TRs: 36.141; 36.307

| ID | WBS | Task | Duration | Start | Finish | Complete | Baseline start | Baseline finish | Baseline duration | Constraint | Resources | Work | Actual work | Acronym | PCG approved | WI rapporteur name | WI rapporteur e-mail | Release | TSG approved | MCC resp | Special Focus Doc | Acronym_3GU_Export | Status Report |
| --- | --- | --- | --- | --- | --- | --- | --- | --- | --- | --- | --- | --- | --- | --- | --- | --- | --- | --- | --- | --- | --- | --- | --- |
| 5136 | 1700.63 | **LTE Advanced 3 Band Carrier Aggregation (3DL/1UL) for Band 2, Band 4 and Band 12** | 268d? | 2013-12-09 A | 2014-12-11 A | 100% | 2013-12-09 | 2014-09-12 | 201d? |  | R4 | 5872h | 5872h | LTE_CA_B2_B4_B12 | 32 | U.S. Cellular | sebastian.thalanany@uscellular.com | Rel-12 | 62 | Issam | CA | LTE_CA_B2_B4_B12 |  |
| 5137 | 1700.63.1 | Core part:LTE Advanced 3 Band Carrier Aggregation (3DL/1UL) for Band 2, Band 4 and Band 12 | 201d? | 2013-12-09 A | 2014-09-12 A | 100% | 2013-12-09 | 2014-09-12 | 201d? | finish no earlier than 2014-09-12 | R4 | 1608h | 1608h | LTE_CA_B2_B4_B12-Core | 32 | U.S. Cellular | sebastian.thalanany@uscellular.com | Rel-12 | 62 | Issam | CA | LTE_CA_B2_B4_B12-Core | RP-141084 |
| 5138 | 1700.63.2 | Perf. part:LTE Advanced 3 Band Carrier Aggregation (3DL/1UL) for Band 2, Band 4 and Band 12 | 265d? | 2013-12-09 A | 2014-12-11 A | 100% | 2013-12-09 | 2014-09-12 | 201d? | finish no earlier than 2014-12-11 | R4 | 2120h | 2120h | LTE_CA_B2_B4_B12-Perf | 32 | U.S. Cellular | sebastian.thalanany@uscellular.com | Rel-12 | 62 | Issam | CA | LTE_CA_B2_B4_B12-Perf | RP-141084 |
| 5139 | 1700.64 | **LTE Advanced 3 Band Carrier Aggregation (3DL/1UL) for Band 2, Band 5 and Band 12** | 202d? | 2013-12-09 A | 2014-09-12 A | 100% | 2013-12-09 | 2014-09-12 | 201d? |  | R4 | 4832h | 4832h | LTE_CA_B2_B5_B12 | 32 | U.S. Cellular | sebastian.thalanany@uscellular.com | Rel-12 | 62 | Issam | CA | LTE_CA_B2_B5_B12 |  |
| 5140 | 1700.64.1 | Core part:LTE Advanced 3 Band Carrier Aggregation (3DL/1UL) for Band 2, Band 5 and Band 12 | 201d? | 2013-12-09 A | 2014-09-12 A | 100% | 2013-12-09 | 2014-09-12 | 201d? | finish no earlier than 2014-09-12 | R4 | 1608h | 1608h | LTE_CA_B2_B5_B12-Core | 32 | U.S. Cellular | sebastian.thalanany@uscellular.com | Rel-12 | 62 | Issam | CA | LTE_CA_B2_B5_B12-Core | RP-141084 |
| 5141 | 1700.64.2 | Perf. part:LTE Advanced 3 Band Carrier Aggregation (3DL/1UL) for Band 2, Band 5 and Band 12 | 201d? | 2013-12-10 A | 2014-09-12 A | 100% | 2013-12-09 | 2014-09-12 | 201d? | finish no earlier than 2014-09-12 | R4 | 1608h | 1608h | LTE_CA_B2_B5_B12-Perf | 32 | U.S. Cellular | sebastian.thalanany@uscellular.com | Rel-12 | 62 | Issam | CA | LTE_CA_B2_B5_B12-Perf | RP-141084 |
| 5142 | 1700.65 | **LTE Advanced 3 Band Carrier Aggregation (3DL/1UL) for Band 2, Band 12 and Band 12** | 202d? | 2013-12-09 A | 2014-09-12 A | 100% | 2013-12-09 | 2014-09-12 | 201d? |  | R4 | 4832h | 4832h | LTE_CA_B2_B12_B12 | 32 | AT&T | marc.grant@att.com | Rel-12 | 62 | Issam | CA | LTE_CA_B2_B12_B12 |  |
| 5143 | 1700.65.1 | Core part:LTE Advanced 3 Band Carrier Aggregation (3DL/1UL) for Band 2, Band 12 and Band 12 | 201d? | 2013-12-09 A | 2014-09-12 A | 100% | 2013-12-09 | 2014-09-12 | 201d? | finish no earlier than 2014-09-12 | R4 | 1608h | 1608h | LTE_CA_B2_B12_B12-Core | 32 | AT&T | marc.grant@att.com | Rel-12 | 62 | Issam | CA | LTE_CA_B2_B12_B12-Core | RP-141084 |
| 5144 | 1700.65.2 | Perf. part:LTE Advanced 3 Band Carrier Aggregation (3DL/1UL) for Band 2, Band 12 and Band 12 | 201d? | 2013-12-09 A | 2014-09-12 A | 100% | 2013-12-09 | 2014-09-12 | 201d? | finish no earlier than 2014-09-12 | R4 | 1608h | 1608h | LTE_CA_B2_B12_B12-Perf | 32 | AT&T | marc.grant@att.com | Rel-12 | 62 | Issam | CA | LTE_CA_B2_B12_B12-Perf | RP-141084 |
| 5145 | 1700.66 | **LTE Advanced 3 Band Carrier Aggregation (3DL/1UL) for Band 2, Band 12 and Band 30** | 202d? | 2013-12-09 A | 2014-09-12 A | 100% | 2013-12-09 | 2014-09-12 | 201d? |  | R4 | 4832h | 4832h | LTE_CA_B2_B12_B30 | 32 | AT&T | marc.grant@att.com | Rel-12 | 62 | Issam | CA | LTE_CA_B2_B12_B30 |  |
| 5146 | 1700.66.1 | Core part:LTE Advanced 3 Band Carrier Aggregation (3DL/1UL) for Band 2, Band 12 and Band 30 | 201d? | 2013-12-09 A | 2014-09-12 A | 100% | 2013-12-09 | 2014-09-12 | 201d? | finish no earlier than 2014-09-12 | R4 | 1608h | 1608h | LTE_CA_B2_B12_B30-Core | 32 | AT&T | marc.grant@att.com | Rel-12 | 62 | Issam | CA | LTE_CA_B2_B12_B30-Core | RP-141084 |
| 5147 | 1700.66.2 | Perf. part:LTE Advanced 3 Band Carrier Aggregation (3DL/1UL) for Band 2, Band 12 and Band 30 | 201d? | 2013-12-09 A | 2014-09-12 A | 100% | 2013-12-09 | 2014-09-12 | 201d? | finish no earlier than 2014-09-12 | R4 | 1608h | 1608h | LTE_CA_B2_B12_B30-Perf | 32 | AT&T | marc.grant@att.com | Rel-12 | 62 | Issam | CA | LTE_CA_B2_B12_B30-Perf | RP-141084 |
| 5148 | 1700.67 | **LTE Advanced 3 Band Carrier Aggregation (3DL/1UL) for Band 3, Band 7 and Band 20** | 202d? | 2013-12-09 A | 2014-09-12 A | 100% | 2013-12-09 | 2014-09-12 | 201d? |  | R4 | 4832h | 4832h | LTE_CA_B3_B7_B20 | 32 | Vodafone | luis.anaya@vodafone.com | Rel-12 | 62 | Issam | CA | LTE_CA_B3_B7_B20 |  |
| 5149 | 1700.67.1 | Core part:LTE Advanced 3 Band Carrier Aggregation (3DL/1UL) for Band 3, Band 7 and Band 20 | 201d? | 2013-12-09 A | 2014-09-12 A | 100% | 2013-12-09 | 2014-09-12 | 201d? | finish no earlier than 2014-09-12 | R4 | 1608h | 1608h | LTE_CA_B3_B7_B20-Core | 32 | Vodafone | luis.anaya@vodafone.com | Rel-12 | 62 | Issam | CA | LTE_CA_B3_B7_B20-Core | RP-141084 |
| 5150 | 1700.67.2 | Perf. part:LTE Advanced 3 Band Carrier Aggregation (3DL/1UL) for Band 3, Band 7 and Band 20 | 201d? | 2013-12-10 A | 2014-09-12 A | 100% | 2013-12-09 | 2014-09-12 | 201d? | finish no earlier than 2014-09-12 | R4 | 1608h | 1608h | LTE_CA_B3_B7_B20-Perf | 32 | Vodafone | luis.anaya@vodafone.com | Rel-12 | 62 | Issam | CA | LTE_CA_B3_B7_B20-Perf | RP-141084 |
| 5151 | 1700.68 | **LTE Advanced 3 Band Carrier Aggregation (3DL/1UL) for Band 4, Band 5 and Band 12** | 202d? | 2013-12-09 A | 2014-09-12 A | 100% | 2013-12-09 | 2014-09-12 | 201d? |  | R4 | 4832h | 4832h | LTE_CA_B4_B5_B12 | 32 | U.S. Cellular | sebastian.thalanany@uscellular.com | Rel-12 | 62 | Issam | CA | LTE_CA_B4_B5_B12 |  |
| 5152 | 1700.68.1 | Core part:LTE Advanced 3 Band Carrier Aggregation (3DL/1UL) for Band 4, Band 5 and Band 12 | 201d? | 2013-12-09 A | 2014-09-12 A | 100% | 2013-12-09 | 2014-09-12 | 201d? | finish no earlier than 2014-09-12 | R4 | 1608h | 1608h | LTE_CA_B4_B5_B12-Core | 32 | U.S. Cellular | sebastian.thalanany@uscellular.com | Rel-12 | 62 | Issam | CA | LTE_CA_B4_B5_B12-Core | RP-141084 |
| 5153 | 1700.68.2 | Perf. part:LTE Advanced 3 Band Carrier Aggregation (3DL/1UL) for Band 4, Band 5 and Band 12 | 201d? | 2013-12-09 A | 2014-09-12 A | 100% | 2013-12-09 | 2014-09-12 | 201d? | finish no earlier than 2014-09-12 | R4 | 1608h | 1608h | LTE_CA_B4_B5_B12-Perf | 32 | U.S. Cellular | sebastian.thalanany@uscellular.com | Rel-12 | 62 | Issam | CA | LTE_CA_B4_B5_B12-Perf | RP-141084 |
| 5154 | 1700.69 | **LTE Advanced 3 Band Carrier Aggregation (3DL/1UL) for Band 4, Band 12 and Band 12** | 202d? | 2013-12-09 A | 2014-09-12 A | 100% | 2013-12-09 | 2014-09-12 | 201d? |  | R4 | 4832h | 4832h | LTE_CA_B4_B12_B12 | 32 | AT&T | marc.grant@att.com | Rel-12 | 62 | Issam | CA | LTE_CA_B4_B12_B12 |  |
| 5155 | 1700.69.1 | Core part:LTE Advanced 3 Band Carrier Aggregation (3DL/1UL) for Band 4, Band 12 and Band 12 | 201d? | 2013-12-09 A | 2014-09-12 A | 100% | 2013-12-09 | 2014-09-12 | 201d? | finish no earlier than 2014-09-12 | R4 | 1608h | 1608h | LTE_CA_B4_B12_B12-Core | 32 | AT&T | marc.grant@att.com | Rel-12 | 62 | Issam | CA | LTE_CA_B4_B12_B12-Core | RP-141084 |
| 5156 | 1700.69.2 | Perf. part:LTE Advanced 3 Band Carrier Aggregation (3DL/1UL) for Band 4, Band 12 and Band 12 | 201d? | 2013-12-09 A | 2014-09-12 A | 100% | 2013-12-09 | 2014-09-12 | 201d? | finish no earlier than 2014-09-12 | R4 | 1608h | 1608h | LTE_CA_B4_B12_B12-Perf | 32 | AT&T | marc.grant@att.com | Rel-12 | 62 | Issam | CA | LTE_CA_B4_B12_B12-Perf | RP-141084 |
| 5157 | 1700.70 | **LTE Advanced 3 Band Carrier Aggregation (3DL/1UL) for Band 4, Band 12 and Band 30** | 202d? | 2013-12-09 A | 2014-09-12 A | 100% | 2013-12-09 | 2014-09-12 | 201d? |  | R4 | 4832h | 4832h | LTE_CA_B4_B12_B30 | 32 | AT&T | marc.grant@att.com | Rel-12 | 62 | Issam | CA | LTE_CA_B4_B12_B30 |  |
| 5158 | 1700.70.1 | Core part:LTE Advanced 3 Band Carrier Aggregation (3DL/1UL) for Band 4, Band 12 and Band 30 | 201d? | 2013-12-09 A | 2014-09-12 A | 100% | 2013-12-09 | 2014-09-12 | 201d? | finish no earlier than 2014-09-12 | R4 | 1608h | 1608h | LTE_CA_B4_B12_B30-Core | 32 | AT&T | marc.grant@att.com | Rel-12 | 62 | Issam | CA | LTE_CA_B4_B12_B30-Core | RP-141084 |
| 5159 | 1700.70.2 | Perf. part:LTE Advanced 3 Band Carrier Aggregation (3DL/1UL) for Band 4, Band 12 and Band 30 | 201d? | 2013-12-09 A | 2014-09-12 A | 100% | 2013-12-09 | 2014-09-12 | 201d? | finish no earlier than 2014-09-12 | R4 | 1608h | 1608h | LTE_CA_B4_B12_B30-Perf | 32 | AT&T | marc.grant@att.com | Rel-12 | 62 | Issam | CA | LTE_CA_B4_B12_B30-Perf | RP-141084 |

Notes:
- 5136: Inter-band CA 3DL / Impacted TSs and TRs: LTE
- 5137: RP#65 completed / Impacted TSs and TRs: 36.101; 36.104; 36.133; new generic 36.853 (3 Band CA with 1UL)
- 5138: RP#65 completion 09/14=>12/14 / Impacted TSs and TRs: 36.141; 36.307
- 5139: Inter-band CA 3DL / Impacted TSs and TRs: LTE
- 5140: RP#65 completed / Impacted TSs and TRs: 36.101; 36.104; 36.133; new generic 36.853 (3 Band CA with 1UL)
- 5141: RP#65 completed / Impacted TSs and TRs: 36.141; 36.307
- 5142: Inter-band CA 3DL / Impacted TSs and TRs: LTE
- 5143: RP#65 completed / Impacted TSs and TRs: 36.101; 36.104; 36.133; 36.141; 36.307; new generic 36.853
- 5144: RP#65 completed / Impacted TSs and TRs: 36.101; 36.104; 36.133; 36.141; 36.307
- 5145: Inter-band CA 3DL / Impacted TSs and TRs: LTE
- 5146: RP#65 completed. Updated WID RP-131652=>RP-141211. / Impacted TSs and TRs: 36.101; 36.104; 36.133; 36.141; 36.307; new generic 36.853 (3 Band CA with 1UL)
- 5147: RP#65 completed / Impacted TSs and TRs: 36.101; 36.104; 36.133; 36.141; 36.307
- 5148: Inter-band CA 3DL / Impacted TSs and TRs: LTE
- 5149: RP#65 completed. Updated WID RP-140244=>RP-141224 / Impacted TSs and TRs: 36.101; 36.104; 36.133; new generic 36.853 (3 Band CA with 1UL)
- 5150: RP#65 completed / Impacted TSs and TRs: 36.101; 36.133; 36.141; 36.307
- 5151: Inter-band CA 3DL / Impacted TSs and TRs: LTE
- 5152: RP#65 completed / Impacted TSs and TRs: 36.101; 36.104; 36.133; new generic 36.853 (3 Band CA with 1UL)
- 5153: RP#65 completed / Impacted TSs and TRs: 36.141; 36.307
- 5154: Inter-band CA 3DL / Impacted TSs and TRs: LTE
- 5155: RP#65 completed / Impacted TSs and TRs: 36.101; 36.104; 36.133; 36.141; 36.307; new generic 36.853 (3 Band CA with 1UL)
- 5156: RP#65 completed / Impacted TSs and TRs: 36.101; 36.104; 36.133; 36.141; 36.307
- 5157: Inter-band CA 3DL / Impacted TSs and TRs: LTE
- 5158: RP#65 completed. Updated WID RP-131653=>RP-141214 / Impacted TSs and TRs: 36.101; 36.104; 36.133; 36.141; 36.307; new generic 36.853 (3 Band CA with 1UL)
- 5159: RP#65 completed / Impacted TSs and TRs: 36.101; 36.104; 36.133; 36.141; 36.307

| ID | WBS | Task | Duration | Start | Finish | Complete | Baseline start | Baseline finish | Baseline duration | Constraint | Resources | Work | Actual work | Acronym | PCG approved | WI rapporteur name | WI rapporteur e-mail | Release | TSG approved | MCC resp | Special Focus Doc | Acronym_3GU_Export | Status Report |
| --- | --- | --- | --- | --- | --- | --- | --- | --- | --- | --- | --- | --- | --- | --- | --- | --- | --- | --- | --- | --- | --- | --- | --- |
| 5160 | 1700.71 | **LTE Advanced intra-band contiguous Carrier Aggregation in Band 42** | 136d? | 2013-12-09 A | 2014-06-13 A | 100% | 2013-12-09 | 2014-06-13 | 136d? |  | R4 | 3264h | 3264h | LTE_CA_C_B42 | 32 | CATT | Yuexia Song (songyuexia@catt.cn) | Rel-12 | 62 | Issam | CA | LTE_CA_C_B42 |  |
| 5161 | 1700.71.1 | Core part: LTE Advanced intra-band contiguous Carrier Aggregation in Band 42 | 136d? | 2013-12-09 A | 2014-06-13 A | 100% | 2013-12-09 | 2014-06-13 | 136d? | finish no earlier than 2014-06-13 | R4 | 1088h | 1088h | LTE_CA_C_B42-Core | 32 | CATT | Yuexia Song (songyuexia@catt.cn) | Rel-12 | 62 | Issam | CA | LTE_CA_C_B42-Core | RP-140569 |
| 5162 | 1700.71.2 | Perf. part: LTE Advanced intra-band contiguous Carrier Aggregation in Band 42 | 136d? | 2013-12-09 A | 2014-06-13 A | 100% | 2013-12-09 | 2014-06-13 | 136d? | finish no earlier than 2014-06-13 | R4 | 1088h | 1088h | LTE_CA_C_B42-Perf | 32 | CATT | Yuexia Song (songyuexia@catt.cn) | Rel-12 | 62 | Issam | CA | LTE_CA_C_B42-Perf | RP-140569 |
| 5163 | 1700.72 | **LTE Advanced intra-band contiguous Carrier Aggregation in Band 7 - Additional bandwidth combinations** | 136d? | 2013-12-09 A | 2014-06-13 A | 100% | 2013-12-09 | 2014-06-13 | 136d? |  | R4 | 3264h | 3264h | LTE_CA_C_B7_BW | 32 | Orange | Olfa BEN HADDADA | Rel-12 | 62 | Issam | CA | LTE_CA_C_B7_BW |  |
| 5164 | 1700.72.1 | Core part: LTE Advanced intra-band contiguous Carrier Aggregation in Band 7 - Additional bandwidth combinations | 136d? | 2013-12-09 A | 2014-06-13 A | 100% | 2013-12-09 | 2014-06-13 | 136d? | finish no earlier than 2014-06-13 | R4 | 1088h | 1088h | LTE_CA_C_B7_BW-Core | 32 | Orange | Olfa BEN HADDADA | Rel-12 | 62 | Issam | CA | LTE_CA_C_B7_BW-Core | RP-140569 |
| 5165 | 1700.72.2 | Perf. part: LTE Advanced intra-band contiguous Carrier Aggregation in Band 7 - Additional bandwidth combinations | 136d? | 2013-12-09 A | 2014-06-13 A | 100% | 2013-12-09 | 2014-06-13 | 136d? | finish no earlier than 2014-06-13 | R4 | 1088h | 1088h | LTE_CA_C_B7_BW-Perf | 32 | Orange | Olfa BEN HADDADA | Rel-12 | 62 | Issam | CA | LTE_CA_C_B7_BW-Perf | RP-140569 |
| 5166 | 1700.73 | **LTE Advanced intra-band non-contiguous Carrier Aggregation in Band 41 for 3 DL** | 334d? | 2013-12-09 A | 2015-03-13 A | 100% | 2013-12-09 | 2014-09-12 | 200d? |  | R4 | 6920h | 6920h | LTE_CA_NC_B41_3DL | 32 | Sprint, Alcatel-Lucent | man-hung.ng@alcatel-lucent.com | Rel-12 | 62 | Issam | CA | LTE_CA_NC_B41_3DL |  |
| 5167 | 1700.73.1 | Core part:LTE Advanced intra-band non-contiguous Carrier Aggregation in Band 41 for 3 DL | 200d? | 2013-12-09 A | 2014-09-11 A | 100% | 2013-12-09 | 2014-09-12 | 200d? | finish no earlier than 2014-09-12 | R4 | 1600h | 1600h | LTE_CA_NC_B41_3DL-Core | 32 | Sprint, Alcatel-Lucent | man-hung.ng@alcatel-lucent.com | Rel-12 | 62 | Issam | CA | LTE_CA_NC_B41_3DL-Core | RP-141084 |
| 5168 | 1700.73.2 | Perf. part:LTE Advanced intra-band non-contiguous Carrier Aggregation in Band 41 for 3 DL | 331d? | 2013-12-09 A | 2015-03-13 A | 100% | 2013-12-09 | 2014-09-12 | 200d? | finish no earlier than 2015-03-15 | R4 | 2648h | 2648h | LTE_CA_NC_B41_3DL-Perf | 32 | Sprint, Alcatel-Lucent | man-hung.ng@alcatel-lucent.com | Rel-12 | 62 | Issam | CA | LTE_CA_NC_B41_3DL-Perf | RP-150013 |
| 5169 | 1700.74 | **LTE Advanced intra-band non-contiguous Carrier Aggregation in Band 42** | 136d? | 2013-12-09 A | 2014-06-13 A | 100% | 2013-12-09 | 2014-06-13 | 136d? |  | R4 | 3264h | 3264h | LTE_CA_NC_B42 | 32 | Huawei | Liu Liehai (liuliehai@huawei.com) | Rel-12 | 62 | Issam | CA | LTE_CA_NC_B42 |  |
| 5170 | 1700.74.1 | Core part:LTE Advanced intra-band non-contiguous Carrier Aggregation in Band 42 | 136d? | 2013-12-09 A | 2014-06-13 A | 100% | 2013-12-09 | 2014-06-13 | 136d? | finish no earlier than 2014-06-13 | R4 | 1088h | 1088h | LTE_CA_NC_B42-Core | 32 | Huawei | Liu Liehai (liuliehai@huawei.com) | Rel-12 | 62 | Issam | CA | LTE_CA_NC_B42-Core | RP-140569 |
| 5171 | 1700.74.2 | Perf. part:LTE Advanced intra-band non-contiguous Carrier Aggregation in Band 42 | 136d? | 2013-12-09 A | 2014-06-13 A | 100% | 2013-12-09 | 2014-06-13 | 136d? | finish no earlier than 2014-06-13 | R4 | 1088h | 1088h | LTE_CA_NC_B42-Perf | 32 | Huawei | Liu Liehai (liuliehai@huawei.com) | Rel-12 | 62 | Issam | CA | LTE_CA_NC_B42-Perf | RP-140569 |
| 5172 | 1700.75 | **LTE Advanced 3 Band Carrier Aggregation (3DL/1UL) for Band 1, Band 3 and Band 5** | 203d? | 2013-12-06 A | 2014-09-12 A | 100% | 2013-12-06 | 2014-09-12 | 202d? |  | R4 | 4856h | 4856h | LTE_CA_B1_B3_B5 | 32 | SK Telecom | haesung.park@sk.com | Rel-12 | 62 | Issam | CA | LTE_CA_B1_B3_B5 |  |
| 5173 | 1700.75.1 | Core part:LTE Advanced 3 Band Carrier Aggregation(3DL/1UL) for Band 1, Band 3 and Band 5 | 202d? | 2013-12-06 A | 2014-09-12 A | 100% | 2013-12-06 | 2014-09-12 | 202d? | finish no earlier than 2014-09-12 | R4 | 1616h | 1616h | LTE_CA_B1_B3_B5-Core | 32 | SK Telecom | haesung.park@sk.com | Rel-12 | 62 | Issam | CA | LTE_CA_B1_B3_B5-Core | RP-141084 |
| 5174 | 1700.75.2 | Perf. part:LTE Advanced 3 Band Carrier Aggregation(3DL/1UL) for Band 1, Band 3 and Band 5 | 202d? | 2013-12-06 A | 2014-09-12 A | 100% | 2013-12-06 | 2014-09-12 | 202d? | finish no earlier than 2014-09-12 | R4 | 1616h | 1616h | LTE_CA_B1_B3_B5-Perf | 32 | SK Telecom | haesung.park@sk.com | Rel-12 | 62 | Issam | CA | LTE_CA_B1_B3_B5-Perf | RP-141084 |
| 5175 | 1700.76 | **LTE Advanced 3 Band Carrier Aggregation (3DL/1UL) for Band 1, Band 3 and Band 20** | 202d? | 2013-12-09 A | 2014-09-12 A | 100% | 2013-12-09 | 2014-09-12 | 201d? |  | R4 | 4832h | 4832h | LTE_CA_B1_B3_B20 | 32 | Vodafone | luis.anaya@vodafone.com | Rel-12 | 62 | Issam | CA | LTE_CA_B1_B3_B20 |  |
| 5176 | 1700.76.1 | Core part:LTE Advanced 3 Band Carrier Aggregation (3DL/1UL) for Band 1, Band 3 and Band 20 | 201d? | 2013-12-09 A | 2014-09-12 A | 100% | 2013-12-09 | 2014-09-12 | 201d? | finish no earlier than 2014-09-12 | R4 | 1608h | 1608h | LTE_CA_B1_B3_B20-Core | 32 | Vodafone | luis.anaya@vodafone.com | Rel-12 | 62 | Issam | CA | LTE_CA_B1_B3_B20-Core | RP-141084 |
| 5177 | 1700.76.2 | Perf. part:LTE Advanced 3 Band Carrier Aggregation (3DL/1UL) for Band 1, Band 3 and Band 20 | 201d? | 2013-12-10 A | 2014-09-12 A | 100% | 2013-12-09 | 2014-09-12 | 201d? | finish no earlier than 2014-09-12 | R4 | 1608h | 1608h | LTE_CA_B1_B3_B20-Perf | 32 | Vodafone | luis.anaya@vodafone.com | Rel-12 | 62 | Issam | CA | LTE_CA_B1_B3_B20-Perf | RP-141084 |
| 5178 | 1700.77 | **LTE Advanced 3 Band Carrier Aggregation (3DL/1UL) for Band 1, Band 7 and Band 20** | 202d? | 2013-12-09 A | 2014-09-12 A | 100% | 2013-12-09 | 2014-09-12 | 201d? |  | R4 | 4832h | 4832h | LTE_CA_B1_B7_B20 | 32 | Vodafone | luis.anaya@vodafone.com | Rel-12 | 62 | Issam | CA | LTE_CA_B1_B7_B20 |  |
| 5179 | 1700.77.1 | Core part:LTE Advanced 3 Band Carrier Aggregation (3DL/1UL) for Band 1, Band 7 and Band 20 | 201d? | 2013-12-09 A | 2014-09-12 A | 100% | 2013-12-09 | 2014-09-12 | 201d? | finish no earlier than 2014-09-12 | R4 | 1608h | 1608h | LTE_CA_B1_B7_B20-Core | 32 | Vodafone | luis.anaya@vodafone.com | Rel-12 | 62 | Issam | CA | LTE_CA_B1_B7_B20-Core | RP-141084 |
| 5180 | 1700.77.2 | Perf. part:LTE Advanced 3 Band Carrier Aggregation (3DL/1UL) for Band 1, Band 7 and Band 20 | 201d? | 2013-12-10 A | 2014-09-12 A | 100% | 2013-12-09 | 2014-09-12 | 201d? | finish no earlier than 2014-09-12 | R4 | 1608h | 1608h | LTE_CA_B1_B7_B20-Perf | 32 | Vodafone | luis.anaya@vodafone.com | Rel-12 | 62 | Issam | CA | LTE_CA_B1_B7_B20-Perf | RP-141084 |
| 5181 | 1700.78 | **LTE Advanced 3 Band Carrier Aggregation (3DL/1UL) for Band 7, Band 8 and Band 20** | 270d? | 2013-12-09 A | 2014-12-15 A | 100% | 2013-12-09 | 2014-09-12 | 201d? |  | R4 | 6432h | 6432h | LTE_CA_B7_B8_B20 | 32 | Vodafone | luis.anaya@vodafone.com | Rel-12 | 62 | Issam | CA | LTE_CA_B7_B8_B20 |  |
| 5182 | 1700.78.1 | Core part:LTE Advanced 3 Band Carrier Aggregation (3DL/1UL) for Band 7, Band 8 and Band 20 | 267d? | 2013-12-09 A | 2014-12-15 A | 100% | 2013-12-09 | 2014-09-12 | 201d? | finish no earlier than 2014-12-15 | R4 | 2136h | 2136h | LTE_CA_B7_B8_B20-Core | 32 | Vodafone | luis.anaya@vodafone.com | Rel-12 | 62 | Issam | CA | LTE_CA_B7_B8_B20-Core | RP-141732 |
| 5183 | 1700.78.2 | Perf. part:LTE Advanced 3 Band Carrier Aggregation (3DL/1UL) for Band 7, Band 8 and Band 20 | 267d? | 2013-12-12 A | 2014-12-15 A | 100% | 2013-12-09 | 2014-09-12 | 201d? | finish no earlier than 2014-12-15 | R4 | 2136h | 2136h | LTE_CA_B7_B8_B20-Perf | 32 | Vodafone | luis.anaya@vodafone.com | Rel-12 | 62 | Issam | CA | LTE_CA_B7_B8_B20-Perf | RP-141732 |

Notes:
- 5160: Intra-band contig. CA 2DL/2UL / Impacted TSs and TRs: LTE
- 5161: RP#64 completed. TR 36.833-1-42v100 for 1-step Approval. Updated WID RP-132029=>RP-140728 / Impacted TSs and TRs: 36.101; 36.104; 36.133; new 36.833-1-42
- 5162: RP#64 completed. TR 36.833-1-42v100 for 1-step Approval. Updated WID RP-132029=>RP-140728 / Impacted TSs and TRs: 36.141; 36.307
- 5163: Intra-band contig. CA 2DL/2UL / Impacted TSs and TRs: LTE
- 5164: RP#64 completed / Impacted TSs and TRs: 36.101; 36.307
- 5165: RP#64 completed / Impacted TSs and TRs: 36.307
- 5166: Intra-band non-contig. CA 3DL / Impacted TSs and TRs: LTE
- 5167: RP#65 completed / Impacted TSs and TRs: 36.101; 36.104; 36.133; 36.307; new 36.833-6-xy
- 5168: CD:Thu 12/03/15->Sun 15/03/15¦Compl:60%->70%¦Stat Rep: RP-141084->RP-141732 1st Apr 15: Compl:70%->100% 1st Apr 15: Stat Rep: RP-141732->RP-150013 / Impacted TSs and TRs: 36.141
- 5169: Intra-band non-contig. CA 2DL / Impacted TSs and TRs: LTE
- 5170: RP#64 completed. Updated WID RP-140404=>RP-140671. TR 36.833-2-42v100 for 1-step Approval / Impacted TSs and TRs: 36.101; 36.104; 36.133; new 36.833-2-42
- 5171: RP#64 completed / Impacted TSs and TRs: 36.141; 36.307
- 5172: Inter-band CA 3DL / Impacted TSs and TRs: LTE
- 5173: RP#65 completed. Updated WID RP-132121=>RP-141454 / Impacted TSs and TRs: 36.101; 36.104; 36.133; new generic 36.853 (3 Band CA with 1UL)
- 5174: RP#65 completed. Updated WID RP-132121=>RP-141454 / Impacted TSs and TRs: 36.141; 36.307
- 5175: Inter-band CA 3DL / Impacted TSs and TRs: LTE
- 5176: RP#65 completed. Updated WID RP-141017=>RP-141222 / Impacted TSs and TRs: 36.101; 36.104; 36.133; new generic 36.851 (2 Band CA with 1UL); 36.853 (3 Band CA with 1UL)
- 5177: RP#65 completed / Impacted TSs and TRs: 36.101; 36.133; 36.141; 36.307
- 5178: Inter-band CA 3DL / Impacted TSs and TRs: LTE
- 5179: RP#65 completed. Updated WID RP-140243=>RP-141223 / Impacted TSs and TRs: 36.101; 36.104; 36.133; new generic 36.853 (3 Band CA with 1UL); 36.851 (2 Band CA with 1UL)
- 5180: RP#65 completed / Impacted TSs and TRs: 36.101; 36.133; 36.141; 36.307
- 5181: Inter-band CA 3DL / Impacted TSs and TRs: LTE
- 5182: CD:Thu 11/12/14->Mon 15/12/14¦Compl:85%->100%¦Stat Rep: RP-141084->RP-141732 / Impacted TSs and TRs: 36.101; 36.104; 36.133; new generic 36.853 (3 Band CA with 1UL); 36.851 (2 Band CA with 1UL)
- 5183: CD:Thu 11/12/14->Mon 15/12/14¦Compl:0%->100%¦Stat Rep: RP-141084->RP-141732 / Impacted TSs and TRs: 36.101; 36.133; 36.141; 36.307

| ID | WBS | Task | Duration | Start | Finish | Complete | Baseline start | Baseline finish | Baseline duration | Constraint | Resources | Work | Actual work | Acronym | PCG approved | WI rapporteur name | WI rapporteur e-mail | Release | TSG approved | MCC resp | Special Focus Doc | Acronym_3GU_Export | Status Report | PCG stopped | TSG stopped |
| --- | --- | --- | --- | --- | --- | --- | --- | --- | --- | --- | --- | --- | --- | --- | --- | --- | --- | --- | --- | --- | --- | --- | --- | --- | --- |
| 5184 | 1700.79 | **Additional bandwidth combinations for LTE Advanced inter-band Carrier Aggregation of Band 2 and Band 29 and of Band 4 and Band 29** | 4d? | 2014-03-03 A | 2014-03-06 A | 100% | 2014-03-03 | 2014-03-06 | 4d? |  | R4 | 64h | 64h | LTE_DL_FDD700_B29_Bwset | 32 | AT&T | marc.grant@att.com | Rel-12 | 63 | Issam | CA | LTE_DL_FDD700_B29_Bwset |  |  |  |
| 5185 | 1700.79.1 | Core part: Additional bandwidth combinations for LTE Advanced inter-band Carrier Aggregation of Band 2 and Band 29 and of Band 4 and Band 29 | 4d? | 2014-03-03 A | 2014-03-06 A | 100% | 2014-03-03 | 2014-03-06 | 4d? | finish no earlier than 2014-03-06 | R4 | 32h | 32h | LTE_DL_FDD700_B29_BWset-Core | 32 | AT&T | marc.grant@att.com | Rel-12 | 63 | Issam | CA | LTE_DL_FDD700_B29_BWset-Core | RP-140428 |  |  |
| 5186 | 1700.80 | **Additional bandwidth combination set for LTE Advanced inter-band Carrier Aggregation of Band 3 and Band 20** | 72d? | 2014-03-06 A | 2014-06-13 A | 100% | 2014-03-06 | 2014-06-13 | 72d? |  | R4 | 1152h | 1152h | LTE_CA_B3_B20_BWset | 32 | NSN | iwajlo.angelow@nsn.com | Rel-12 | 63 | Issam | CA | LTE_CA_B3_B20_BWset |  |  |  |
| 5187 | 1700.80.1 | Core part: Additional bandwidth combination set for LTE Advanced inter-band Carrier Aggregation of Band 3 and Band 20 | 72d? | 2014-03-06 A | 2014-06-13 A | 100% | 2014-03-06 | 2014-06-13 | 72d? | finish no earlier than 2014-06-13 | R4 | 576h | 576h | LTE_CA_B3_B20_BWset-Core | 32 | NSN | iwajlo.angelow@nsn.com | Rel-12 | 63 | Issam | CA | LTE_CA_B3_B20_BWset-Core | RP-140569 |  |  |
| 5188 | 1700.81 | **Additional bandwidth combination set for LTE Advanced inter-band Carrier Aggregation of Band 7 and Band 20** | 72d? | 2014-03-06 A | 2014-06-13 A | 100% | 2014-03-06 | 2014-06-13 | 72d? |  | R4 | 1152h | 1152h | LTE_CA_B7_B20_BWset | 32 | NSN | iwajlo.angelow@nsn.com | Rel-12 | 63 | Issam | CA | LTE_CA_B7_B20_BWset |  |  |  |
| 5189 | 1700.81.1 | Core part: Additional bandwidth combination set for LTE Advanced inter-band Carrier Aggregation of Band 7 and Band 20 | 72d? | 2014-03-06 A | 2014-06-13 A | 100% | 2014-03-06 | 2014-06-13 | 72d? | finish no earlier than 2014-06-13 | R4 | 576h | 576h | LTE_CA_B7_B20_BWset-Core | 32 | NSN | iwajlo.angelow@nsn.com | Rel-12 | 63 | Issam | CA | LTE_CA_B7_B20_BWset-Core | RP-140569 |  |  |
| 5190 | 1700.82 | **Additional bandwidth combinations for LTE Advanced inter-band Carrier Aggregation to support 3DL fallback** | 72d? | 2014-03-06 A | 2014-06-13 A | 100% | 2014-03-06 | 2014-06-13 | 72d? |  | R4 | 1152h | 1152h | LTE_CA_3DL_FB_BW | 32 | Qualcomm | Fong Gene (gfong@qti.qualcomm.com) | Rel-12 | 63 | Issam | CA | LTE_CA_3DL_FB_BW |  |  |  |
| 5191 | 1700.82.1 | Core part: Additional bandwidth combinations for LTE Advanced inter-band Carrier Aggregation to support 3DL fallback | 72d? | 2014-03-06 A | 2014-06-13 A | 100% | 2014-03-06 | 2014-06-13 | 72d? | finish no earlier than 2014-06-13 | R4 | 576h | 576h | LTE_CA_3DL_FB_BW-Core | 32 | Qualcomm | Fong Gene (gfong@qti.qualcomm.com) | Rel-12 | 63 | Issam | CA | LTE_CA_3DL_FB_BW-Core | RP-140569 |  |  |
| 5192 | 1700.83 | **LTE Advanced 3 Band Carrier Aggregation (3DL/1UL) of Band 3, Band 7 and Band 7** | 138d? | 2014-03-06 A | 2014-09-12 A | 100% | 2014-03-06 | 2014-09-12 | 137d? |  | R4 | 3296h | 3296h | LTE_CA_B3_B7_B7 | 32 | Nokia Networks | iwajlo.angelow@nsn.com | Rel-12 | 63 | Issam | CA | LTE_CA_B3_B7_B7 |  |  |  |
| 5193 | 1700.83.1 | Core part:LTE Advanced 3 Band Carrier Aggregation (3DL/1UL) of Band 3, Band 7 and Band 7 | 137d? | 2014-03-06 A | 2014-09-12 A | 100% | 2014-03-06 | 2014-09-12 | 137d? | finish no earlier than 2014-09-12 | R4 | 1096h | 1096h | LTE_CA_B3_B7_B7-Core | 32 | Nokia Networks | iwajlo.angelow@nsn.com | Rel-12 | 63 | Issam | CA | LTE_CA_B3_B7_B7-Core | RP-141084 |  |  |
| 5194 | 1700.83.2 | Perf. part:LTE Advanced 3 Band Carrier Aggregation (3DL/1UL) of Band 3, Band 7 and Band 7 | 137d? | 2014-03-06 A | 2014-09-12 A | 100% | 2014-03-06 | 2014-09-12 | 137d? | finish no earlier than 2014-09-12 | R4 | 1096h | 1096h | LTE_CA_B3_B7_B7-Perf | 32 | Nokia Networks | iwajlo.angelow@nsn.com | Rel-12 | 63 | Issam | CA | LTE_CA_B3_B7_B7-Perf | RP-141084 |  |  |
| 5195 | 1700.84 | **LTE Advanced 3 Band Carrier Aggregation (3DL/1UL) of Band 1, Band 19 and Band 21** | 138d? | 2014-03-06 A | 2014-09-12 A | 100% | 2014-03-06 | 2014-09-12 | 137d? |  | R4 | 3296h | 3296h | LTE_CA_B1_B19_B21 | 32 | NTT DOCOMO | teruaki.toeda.zf@nttdocomo.com | Rel-12 | 63 | Issam | CA | LTE_CA_B1_B19_B21 |  |  |  |
| 5196 | 1700.84.1 | Core part:LTE Advanced 3 Band Carrier Aggregation (3DL/1UL) of Band 1, Band 19 and Band 21 | 137d? | 2014-03-06 A | 2014-09-12 A | 100% | 2014-03-06 | 2014-09-12 | 137d? | finish no earlier than 2014-09-12 | R4 | 1096h | 1096h | LTE_CA_B1_B19_B21-Core | 32 | NTT DOCOMO | teruaki.toeda.zf@nttdocomo.com | Rel-12 | 63 | Issam | CA | LTE_CA_B1_B19_B21-Core | RP-141084 |  |  |
| 5197 | 1700.84.2 | Perf. part:LTE Advanced 3 Band Carrier Aggregation (3DL/1UL) of Band 1, Band 19 and Band 21 | 137d? | 2014-03-06 A | 2014-09-12 A | 100% | 2014-03-06 | 2014-09-12 | 137d? | finish no earlier than 2014-09-12 | R4 | 1096h | 1096h | LTE_CA_B1_B19_B21-Perf | 32 | NTT DOCOMO | teruaki.toeda.zf@nttdocomo.com | Rel-12 | 63 | Issam | CA | LTE_CA_B1_B19_B21-Perf | RP-141084 |  |  |
| 5198 | 1700.85 | **LTE Advanced 3 Band Carrier Aggregation (3DL/1UL) of Band 3, Band 3 and Band 7** | 138d? | 2014-03-06 A | 2014-09-12 A | 100% | 2014-03-06 | 2014-09-12 | 137d? |  | R4 | 3296h | 3296h | LTE_CA_B3_B3_B7 | 32 | TeliaSonera | Ralf.Schuh@TeliaSonera.com | Rel-12 | 63 | Issam | CA | LTE_CA_B3_B3_B7 |  |  |  |
| 5199 | 1700.85.1 | Core part: LTE-Advanced 3 Band Carrier Aggregation (3DL/1UL) of Band 3, Band 3 and Band 7 | 137d? | 2014-03-06 A | 2014-09-12 A | 100% | 2014-03-06 | 2014-09-12 | 137d? | finish no earlier than 2014-09-12 | R4 | 1096h | 1096h | LTE_CA_B3_B3_B7-Core | 32 | TeliaSonera | Ralf.Schuh@TeliaSonera.com | Rel-12 | 63 | Issam | CA | LTE_CA_B3_B3_B7-Core | RP-141084 |  |  |
| 5200 | 1700.85.2 | Perf. part: LTE-Advanced 3 Band Carrier Aggregation (3DL/1UL) of Band 3, Band 3 and Band 7 | 137d? | 2014-03-06 A | 2014-09-12 A | 100% | 2014-03-06 | 2014-09-12 | 137d? | finish no earlier than 2014-09-12 | R4 | 1096h | 1096h | LTE_CA_B3_B3_B7-Perf | 32 | TeliaSonera | Ralf.Schuh@TeliaSonera.com | Rel-12 | 63 | Issam | CA | LTE_CA_B3_B3_B7-Perf | RP-141084 |  |  |
| 5201 | 1700.86 | **LTE Advanced intra-band contiguous Carrier Aggregation in Band 40 for 3DL** | 72d? | 2014-03-06 A | 2014-06-13 A | 100% | 2014-03-06 | 2014-06-13 | 72d? |  | R4 | 1728h | 1728h | LTE_CA_C_B40_3DL | 32 | China Mobile | Pan Qun (panqun@chinamobile.com) | Rel-12 | 63 | Issam | CA | LTE_CA_C_B40_3DL |  |  |  |
| 5202 | 1700.86.1 | Core part: LTE Advanced intra-band contiguous Carrier Aggregation in Band 40 for 3DL | 72d? | 2014-03-06 A | 2014-06-13 A | 100% | 2014-03-06 | 2014-06-13 | 72d? | finish no earlier than 2014-06-13 | R4 | 576h | 576h | LTE_CA_C_B40_3DL-Core | 32 | China Mobile | Pan Qun (panqun@chinamobile.com) | Rel-12 | 63 | Issam | CA | LTE_CA_C_B40_3DL-Core | RP-140569 |  |  |
| 5203 | 1700.86.2 | Perf. part: LTE Advanced intra-band contiguous Carrier Aggregation in Band 40 for 3DL | 72d? | 2014-03-06 A | 2014-06-13 A | 100% | 2014-03-06 | 2014-06-13 | 72d? | finish no earlier than 2014-06-13 | R4 | 576h | 576h | LTE_CA_C_B40_3DL-Perf | 32 | China Mobile | Pan Qun (panqun@chinamobile.com) | Rel-12 | 63 | Issam | CA | LTE_CA_C_B40_3DL-Perf | RP-140569 |  |  |
| 5204 | 1700.87 | **Additional bandwidth combination set for LTE Advanced inter-band Carrier Aggregation of Band 4 and Band 12** | 137d? | 2014-03-07 A | 2014-09-12 A | 100% | 2014-03-06 | 2014-12-05 | 197d? |  | R4 | 3288h | 3288h | LTE_CA_B4_B12_BWset | 32 | T-Mobile USA | nelson.ueng@t-mobile.com | Rel-12 | 63 | Issam | CA | LTE_CA_B4_B12_BWset |  |  |  |
| 5205 | 1700.87.1 | Core part: Additional bandwidth combination set for LTE Advanced inter-band Carrier Aggregation of Band 4 and Band 12 | 137d? | 2014-03-07 A | 2014-09-12 A | 100% | 2014-03-06 | 2014-12-05 | 197d? | finish no earlier than 2014-09-12 | R4 | 1096h | 1096h | LTE_CA_B4_B12_BWset-Core | 32 | T-Mobile USA | nelson.ueng@t-mobile.com | Rel-12 | 63 | Issam | CA | LTE_CA_B4_B12_BWset-Core | RP-141084 |  |  |
| 5206 | 1700.87.2 | Deleted - Perf. part: Additional bandwidth combination set for LTE Advanced inter-band Carrier Aggregation of Band 4 and Band 12 | 137d? | 2014-03-07 A | 2014-09-12 A | 100% | 2014-03-06 | 2014-12-05 | 197d? | finish no earlier than 2014-09-12 | R4 | 1096h | 1096h | LTE_CA_B4_B12_BWset-Perf | 32 | T-Mobile USA | nelson.ueng@t-mobile.com | Rel-12 | 63 | Issam | CA | LTE_CA_B4_B12_BWset-Perf | RP-141084 | PCG-33 | RP-65 |
| 5207 | 1700.88 | **LTE Advanced inter-band Carrier Aggregation of Band 41 and Band 42** | 138d? | 2014-03-06 A | 2014-09-12 A | 100% | 2014-03-06 | 2014-09-12 | 137d? |  | R4 | 2776h | 2776h | LTE_CA_B41_B42 | 32 | Huawei | leo.liuye@huawei.com | Rel-12 | 63 | Issam | CA | LTE_CA_B41_B42 |  |  |  |
| 5208 | 1700.88.1 | Core part:LTE Advanced inter-band Carrier Aggregation of Band 41 and Band 42 | 72d? | 2014-03-06 A | 2014-09-12 A | 100% | 2014-03-06 | 2014-09-12 | 72d? | finish no earlier than 2014-09-12 | R4 | 576h | 576h | LTE_CA_B41_B42-Core | 32 | Huawei | leo.liuye@huawei.com | Rel-12 | 63 | Issam | CA | LTE_CA_B41_B42-Core | RP-141084 |  |  |
| 5209 | 1700.88.2 | Perf. Part:LTE Advanced inter-band Carrier Aggregation of Band 41 and Band 42 | 137d? | 2014-03-07 A | 2014-09-12 A | 100% | 2014-03-06 | 2014-09-12 | 137d? | finish no earlier than 2014-09-12 | R4 | 1096h | 1096h | LTE_CA_B41_B42-Perf | 32 | Huawei | leo.liuye@huawei.com | Rel-12 | 63 | Issam | CA | LTE_CA_B41_B42-Perf | RP-141084 |  |  |

Notes:
- 5184: Inter-band 2DL/1UL / Impacted TSs and TRs: LTE
- 5185: RP#63 approved WI (no Perf. Part) & completed. Rel-10 and Rel-11 versions of 36.307 affected / Impacted TSs and TRs: 36.101; 36.307
- 5186: Inter-band CA 2DL / Impacted TSs and TRs: LTE
- 5187: RP#64 completed / Impacted TSs and TRs: 36.101; 36.851
- 5188: Inter-band CA 2DL / Impacted TSs and TRs: LTE
- 5189: RP#64 completed / Impacted TSs and TRs: 36.101; 36.851
- 5190: Inter-band CA 2DL / Impacted TSs and TRs: LTE
- 5191: RP#64 completed, Additional BW combinations added for 6 Wis: 3 open Rel-12 Wis (B1_B5_B7, B2_B29_B30, B4_B29_B30) and 3 completed Rel-11 Wis (B3_B5, B4_B5, B4_B12) / Impacted TSs and TRs: 36.101; 36.307
- 5192: Inter-band CA 3DL. Mar15: acronym reverted to LTE_CA_B3_B7_B7_ / Impacted TSs and TRs: LTE
- 5193: RP#65 completed. Updated WID RP-140095=>RP-141196. Mar15: acronym reverted to LTE_CA_B3_B7_B7-Core_ / Impacted TSs and TRs: 36.101; 36.104; 36.133; new generic 36.853 (3 Band CA with 1UL)
- 5194: RP#65 completed. Updated WID RP-140095=>RP-141196. Mar15: acronym reverted from LTE_CA_B3_B7_B7-Perf_ / Impacted TSs and TRs: 36.141; 36.307
- 5195: Inter-band CA 3DL / Impacted TSs and TRs: LTE
- 5196: RP#65 completed. Updated WID RP-140106=>RP-141193 / Impacted TSs and TRs: 36.101; 36.104; 36.133; new generic 36.853 (3 Band CA with 1UL)
- 5197: RP#65 completed. Updated WID RP-140106=>RP-141193 / Impacted TSs and TRs: 36.141; 36.307
- 5198: Inter-band CA 3DL / Impacted TSs and TRs: LTE
- 5199: RP#65 completed. Updated RP-140390=>RP-141126 / Impacted TSs and TRs: 36.101; 36.104; 36.133; new generic 36.853 (3 Band CA with 1UL)
- 5200: RP#65 completed. Updated RP-140390=>RP-141126 / Impacted TSs and TRs: 36.141; 36.307
- 5201: Intra-band contig. CA 3DL / Impacted TSs and TRs: LTE
- 5202: RP#64 completed. Updated WID RP-140453=>RP-140948 / Impacted TSs and TRs: 36.101; 36.104; 36.133; New 36.833-5-40
- 5203: RP#64 completed. Updated WID RP-140453=>RP-140948 / Impacted TSs and TRs: 36.141; 36.307
- 5204: Inter-band CA 2DL / Impacted TSs and TRs: LTE
- 5205: RP#65 completed. Updated WID RP-140987=>RP-141235 (removed Perf. Part) / Impacted TSs and TRs: 36.101; generic 36.850
- 5206: RP#65 stopped. Updated WID RP-140987=>RP-141235 (removed Perf. Part) / Impacted TSs and TRs: 36.307
- 5207: Inter-band CA 2DL / Impacted TSs and TRs: LTE
- 5208: RP#65 completed / Impacted TSs and TRs: 36.101; 36.104; 36.851
- 5209: RP#65 completed / Impacted TSs and TRs: 36.141

| ID | WBS | Task | Duration | Start | Finish | Complete | Baseline start | Baseline finish | Baseline duration | Constraint | Resources | Work | Actual work | Acronym | PCG approved | WI rapporteur name | WI rapporteur e-mail | Release | TSG approved | MCC resp | Special Focus Doc | Acronym_3GU_Export | Status Report |
| --- | --- | --- | --- | --- | --- | --- | --- | --- | --- | --- | --- | --- | --- | --- | --- | --- | --- | --- | --- | --- | --- | --- | --- |
| 5210 | 1700.89 | **LTE Advanced 3 Band Carrier Aggregation (3DL/1UL) of Band 4, Band 4, and Band 12** | 138d? | 2014-03-06 A | 2014-09-12 A | 100% | 2014-03-06 | 2014-12-05 | 197d? |  | R4 | 3296h | 3296h | LTE_CA_B4_B4_B12 | 32 | T-Mobile USA | nelson.ueng@t-mobile.com | Rel-12 | 63 | Issam | CA | LTE_CA_B4_B4_B12 |  |
| 5211 | 1700.89.1 | Core part:LTE Advanced 3 Band Carrier Aggregation (3DL/1UL) of Band 4, Band 4, and Band 12 | 137d? | 2014-03-06 A | 2014-09-12 A | 100% | 2014-03-06 | 2014-12-05 | 197d? | finish no earlier than 2014-09-12 | R4 | 1096h | 1096h | LTE_CA_B4_B4_B12-Core | 32 | T-Mobile USA | nelson.ueng@t-mobile.com | Rel-12 | 63 | Issam | CA | LTE_CA_B4_B4_B12-Core | RP-141084 |
| 5212 | 1700.89.2 | Perf. part:LTE Advanced 3 Band Carrier Aggregation (3DL/1UL) of Band 4, Band 4, and Band 12 | 137d? | 2014-03-07 A | 2014-09-12 A | 100% | 2014-03-06 | 2014-12-05 | 197d? | finish no earlier than 2014-09-12 | R4 | 1096h | 1096h | LTE_CA_B4_B4_B12-Perf | 32 | T-Mobile USA | nelson.ueng@t-mobile.com | Rel-12 | 63 | Issam | CA | LTE_CA_B4_B4_B12-Perf | RP-141084 |
| 5213 | 1700.90 | **LTE Advanced 3 Band Carrier Aggregation (3DL/1UL) of Band 2, Band 4, and Band 4** | 138d? | 2014-03-06 A | 2014-09-12 A | 100% | 2014-03-06 | 2014-12-05 | 197d? |  | R4 | 3296h | 3296h | LTE_CA_B2_B4_B4 | 32 | T-Mobile USA | nelson.ueng@T-Mobile.com | Rel-12 | 63 | Issam | CA | LTE_CA_B2_B4_B4 |  |
| 5214 | 1700.90.1 | Core part:LTE Advanced 3 Band Carrier Aggregation (3DL/1UL) of Band 2, Band 4, and Band 4 | 137d? | 2014-03-06 A | 2014-09-12 A | 100% | 2014-03-06 | 2014-12-05 | 197d? | finish no earlier than 2014-09-12 | R4 | 1096h | 1096h | LTE_CA_B2_B4_B4-Core | 32 | T-Mobile USA | nelson.ueng@T-Mobile.com | Rel-12 | 63 | Issam | CA | LTE_CA_B2_B4_B4-Core | RP-141084 |
| 5215 | 1700.90.2 | Perf. part:LTE Advanced 3 Band Carrier Aggregation (3DL/1UL) of Band 2, Band 4, and Band 4 | 137d? | 2014-03-07 A | 2014-09-12 A | 100% | 2014-03-06 | 2014-12-05 | 197d? | finish no earlier than 2014-09-12 | R4 | 1096h | 1096h | LTE_CA_B2_B4_B4-Perf | 32 | T-Mobile USA | nelson.ueng@T-Mobile.com | Rel-12 | 63 | Issam | CA | LTE_CA_B2_B4_B4-Perf | RP-141084 |
| 5216 | 1700.91 | **Additional bandwidth combinations for LTE Advanced intra-band non-contiguous Carrier Aggregation in Band 25** | 138d? | 2014-03-06 A | 2014-09-12 A | 100% | 2014-03-06 | 2014-09-12 | 137d? |  | R4 | 3296h | 3296h | LTE_CA_NC_B25_BWset | 32 | Huawei | Liu Liehai (liuliehai@huawei.com) | Rel-12 | 63 | Issam | CA | LTE_CA_NC_B25_BWset |  |
| 5217 | 1700.91.1 | Core part: Additional bandwidth combinations for LTE Advanced intra-band non-contiguous Carrier Aggregation in Band 25 | 137d? | 2014-03-06 A | 2014-09-12 A | 100% | 2014-03-06 | 2014-09-12 | 137d? | finish no earlier than 2014-09-12 | R4 | 1096h | 1096h | LTE_CA_NC_B25_BWset-Core | 32 | Huawei | Liu Liehai (liuliehai@huawei.com) | Rel-12 | 63 | Issam | CA | LTE_CA_NC_B25_BWset-Core | RP-141084 |
| 5218 | 1700.91.2 | Perf. part: Additional bandwidth combinations for LTE Advanced intra-band non-contiguous Carrier Aggregation in Band 25 | 137d? | 2014-03-07 A | 2014-09-12 A | 100% | 2014-03-06 | 2014-09-12 | 137d? | finish no earlier than 2014-09-12 | R4 | 1096h | 1096h | LTE_CA_NC_B25_BWset-Perf | 32 | Huawei | Liu Liehai (liuliehai@huawei.com) | Rel-12 | 63 | Issam | CA | LTE_CA_NC_B25_BWset-Perf | RP-141084 |
| 5219 | 1700.92 | **Additional bandwidth combination set for LTE Advanced inter-band Carrier Aggregation of Band 2 and Band 4** | 66d? | 2014-06-15 A | 2014-09-12 A | 100% | 2014-06-13 | 2014-09-12 | 66d? |  | R4 | 1056h | 1056h | LTE_CA_B2_B4_Bwset2 | 33 | T-Mobile USA | nelson.ueng@T-Mobile.com | Rel-12 | 64 |  | CA | LTE_CA_B2_B4_BWset |  |
| 5220 | 1700.92.1 | Core part: Additional bandwidth combination set 2 for LTE Advanced inter-band Carrier Aggregation of Band 2 and Band 4 | 66d? | 2014-06-15 A | 2014-09-12 A | 100% | 2014-06-13 | 2014-09-12 | 66d? | finish no earlier than 2014-09-15 | R4 | 528h | 528h | LTE_CA_B2_B4_BWset2-Core | 33 | T-Mobile USA | nelson.ueng@T-Mobile.com | Rel-12 | 64 |  | CA | LTE_CA_B2_B4_BWset-Core | RP-141084 |
| 5221 | 1700.93 | **Additional bandwidth combination set for LTE Advanced inter-band Carrier Aggregation of Band 2 and Band 5** | 132d? | 2014-06-18 A | 2014-12-15 A | 100% | 2014-06-13 | 2014-09-12 | 66d? |  | R4 | 3168h | 3168h | LTE_CA_B2_B5_BWset | 33 | AT&T | marc.grant@att.com | Rel-12 | 64 |  | CA | LTE_CA_B2_B5_BWset |  |
| 5222 | 1700.93.1 | Core part: Additional bandwidth combination set for LTE Advanced inter-band Carrier Aggregation of Band 2 and Band 5 | 132d? | 2014-06-18 A | 2014-12-15 A | 100% | 2014-06-13 | 2014-09-12 | 66d? | finish no earlier than 2014-12-15 | R4 | 1056h | 1056h | LTE_CA_B2_B5_Bwset-Core | 33 | AT&T | marc.grant@att.com | Rel-12 | 64 |  | CA | LTE_CA_B2_B5_Bwset-Core | RP-141732 |
| 5223 | 1700.93.2 | Perf. Part: Additional bandwidth combination set for LTE Advanced inter-band Carrier Aggregation of Band 2 and Band 5 | 132d? | 2014-06-18 A | 2014-12-15 A | 100% | 2014-06-13 | 2014-09-12 | 66d? | finish no earlier than 2014-12-15 | R4 | 1056h | 1056h | LTE_CA_B2_B5_BWset-Perf | 33 | AT&T | marc.grant@att.com | Rel-12 | 64 |  | CA | LTE_CA_B2_B5_BWset-Perf | RP-141732 |
| 5224 | 1700.94 | **E-UTRA UE demodulation/Channel State Information (CSI) performance requirements for multiple Carrier Aggregation configurations** | 198d? | 2014-06-16 A | 2015-03-13 A | 100% | 2014-06-13 | 2015-03-13 | 196d? |  | R4 | 3152h | 3152h | LTE_CA_Mult | 33 | China Mobile | Zhang Xiaoran (zhangxiaoran@chinamobile.com) | Rel-12 | 64 |  | CA | LTE_CA_Mult |  |
| 5225 | 1700.94.1 | Perf. Part: E-UTRA UE demodulation/Channel State Information (CSI) performance requirements for multiple Carrier Aggregation configurations | 196d? | 2014-06-16 A | 2015-03-13 A | 100% | 2014-06-13 | 2015-03-13 | 196d? | finish no earlier than 2015-03-15 | R4 | 1568h | 1568h | LTE_CA_Mult-Perf | 33 | China Mobile | Zhang Xiaoran (zhangxiaoran@chinamobile.com) | Rel-12 | 64 |  | CA | LTE_CA_Mult-Perf | RP-150188 |
| 5226 | 1700.95 | **LTE Advanced 3 Band Carrier Aggregation (3DL/1UL) of Band 1, Band 3 and Band 19** | 66d? | 2014-06-16 A | 2014-09-12 A | 100% | 2014-06-13 | 2014-09-12 | 66d? |  | R4 | 1584h | 1584h | LTE_CA_B1_B3_B19 | 33 | NTT DOCOMO | teruaki.toeda.zf@nttdocomo.com | Rel-12 | 64 |  | CA | LTE_CA_B1_B3_B19 |  |
| 5227 | 1700.95.1 | Core part:LTE Advanced 3 Band Carrier Aggregation (3DL/1UL) of Band 1, Band 3 and Band 19 | 66d? | 2014-06-16 A | 2014-09-12 A | 100% | 2014-06-13 | 2014-09-12 | 66d? | finish no earlier than 2014-09-12 | R4 | 528h | 528h | LTE_CA_B1_B3_B19-Core | 33 | NTT DOCOMO | teruaki.toeda.zf@nttdocomo.com | Rel-12 | 64 |  | CA | LTE_CA_B1_B3_B19-Core | RP-141084 |
| 5228 | 1700.95.2 | Perf. Part:LTE Advanced 3 Band Carrier Aggregation (3DL/1UL) of Band 1, Band 3 and Band 19 | 66d? | 2014-06-16 A | 2014-09-12 A | 100% | 2014-06-13 | 2014-09-12 | 66d? | finish no earlier than 2014-09-12 | R4 | 528h | 528h | LTE_CA_B1_B3_B19-Perf | 33 | NTT DOCOMO | teruaki.toeda.zf@nttdocomo.com | Rel-12 | 64 |  | CA | LTE_CA_B1_B3_B19-Perf | RP-141084 |
| 5229 | 1700.96 | **LTE Advanced 3 Band Carrier Aggregation (3DL/1UL) of Band 19, Band 42 and Band 42** | 66d? | 2014-06-16 A | 2014-09-12 A | 100% | 2014-06-13 | 2014-09-12 | 66d? |  | R4 | 1584h | 1584h | LTE_CA_B19_B42_B42 | 33 | NTT DOCOMO | teruaki.toeda.zf@nttdocomo.com | Rel-12 | 64 |  | CA | LTE_CA_B19_B42_B42 |  |
| 5230 | 1700.96.1 | Core part:LTE Advanced 3 Band Carrier Aggregation (3DL/1UL) of Band 19, Band 42 and Band 42 | 66d? | 2014-06-16 A | 2014-09-12 A | 100% | 2014-06-13 | 2014-09-12 | 66d? | finish no earlier than 2014-09-12 | R4 | 528h | 528h | LTE_CA_B19_B42_B42-Core | 33 | NTT DOCOMO | teruaki.toeda.zf@nttdocomo.com | Rel-12 | 64 |  | CA | LTE_CA_B19_B42_B42-Core | RP-141084 |
| 5231 | 1700.96.2 | Perf. Part:LTE Advanced 3 Band Carrier Aggregation (3DL/1UL) of Band 19, Band 42 and Band 42 | 66d? | 2014-06-16 A | 2014-09-12 A | 100% | 2014-06-13 | 2014-09-12 | 66d? | finish no earlier than 2014-09-12 | R4 | 528h | 528h | LTE_CA_B19_B42_B42-Perf | 33 | NTT DOCOMO | teruaki.toeda.zf@nttdocomo.com | Rel-12 | 64 |  | CA | LTE_CA_B19_B42_B42-Perf | RP-141084 |
| 5232 | 1700.97 | **LTE Advanced 3 Band Carrier Aggregation (3DL/1UL) of Band 3, Band 42 and Band 42** | 198d? | 2014-06-16 A | 2015-03-13 A | 100% | 2014-06-13 | 2014-09-12 | 66d? |  | R4 | 4720h | 4720h | LTE_CA_B3_B42_B42 | 33 | NTT DOCOMO | ANDO Kei (kei.andou.ye@nttdocomo.com) | Rel-12 | 64 |  | CA | LTE_CA_B3_B42_B42 |  |
| 5233 | 1700.97.1 | Core part:LTE Advanced 3 Band Carrier Aggregation (3DL/1UL) of Band 3, Band 42 and Band 42 | 196d? | 2014-06-16 A | 2015-03-13 A | 100% | 2014-06-13 | 2014-09-12 | 66d? | finish no earlier than 2015-03-15 | R4 | 1568h | 1568h | LTE_CA_B3_B42_B42-Core | 33 | NTT DOCOMO | ANDO Kei (kei.andou.ye@nttdocomo.com) | Rel-12 | 64 |  | CA | LTE_CA_B3_B42_B42-Core | RP-150013 |
| 5234 | 1700.97.2 | Perf. Part:LTE Advanced 3 Band Carrier Aggregation (3DL/1UL) of Band 3, Band 42 and Band 42 | 196d? | 2014-06-16 A | 2015-03-13 A | 100% | 2014-06-13 | 2014-09-12 | 66d? | finish no earlier than 2016-03-15 | R4 | 1568h | 1568h | LTE_CA_B3_B42_B42-Perf | 33 | NTT DOCOMO | ANDO Kei (kei.andou.ye@nttdocomo.com) | Rel-12 | 64 |  | CA | LTE_CA_B3_B42_B42-Perf | RP-150013 |

Notes:
- 5210: Inter-band CA 3DL / Impacted TSs and TRs: LTE
- 5211: RP#65 completed. Updated WID RP-140116=>RP-141709 / Impacted TSs and TRs: 36.101; 36.104; 36.133; 36.141; 36.307; generic 36.853 (3 Band CA with 1UL)
- 5212: RP#65 completed / Impacted TSs and TRs: 36.101; 36.104; 36.133; 36.141; 36.307
- 5213: Inter-band CA 3DL / Impacted TSs and TRs: LTE
- 5214: RP#65 completed. Updated WID RP-140117=>RP-141236 / Impacted TSs and TRs: 36.101; 36.104; 36.133; 36.141; 36.307; generic 36.853 (3 Band CA with 1UL)
- 5215: RP#65 completed / Impacted TSs and TRs: 36.101; 36.104; 36.133; 36.141; 36.307
- 5216: Intra-band non-contig. CA 2DL / Impacted TSs and TRs: LTE
- 5217: RP#65 completed / Impacted TSs and TRs: 36.101; 36.307; 36.833-2-25
- 5218: RP#65 completed / Impacted TSs and TRs: 36.307
- 5219: Inter-band CA 2DL. Mar 15: acronym changed from LTE_CA_B2_B4_Bwset_ / Impacted TSs and TRs: LTE
- 5220: Dec 14: Prev CD:Fri 12/09/14¦Prev %:100%, title changed. Mar 15: Acronym changed to LTE_CA_B2_B4_BWset2-Core_ / Impacted TSs and TRs: 36.101; 36.851
- 5221: 2DL/1UL / Impacted TSs and TRs: LTE
- 5222: ¦WID: RP-142043->RP-141803¦Stat Rep: RP-141084->RP-141732 / Impacted TSs and TRs: 36.101; 36.851
- 5223: CD:Thu 11/12/14->Mon 15/12/14¦Compl:0%->0%¦Stat Rep: RP-141084->RP-141732 / Impacted TSs and TRs: 36.307
- 5224: LTE / Impacted TSs and TRs: LTE
- 5225: CD:Thu 12/03/15->Sun 15/03/15¦Compl:10%->90%¦Stat Rep: RP-141303->RP-141839 1st Apr 15: Compl:90%->100% 1st Apr 15: Stat Rep: RP-141839->RP-150188 / Impacted TSs and TRs: 36.101
- 5226: Inter-band CA 3DL / Impacted TSs and TRs: LTE
- 5227: RP#65 completed / Impacted TSs and TRs: 36.101; 36.104; 36.133; generic 36.853 (3 Band CA with 1UL)
- 5228: RP#65 completed / Impacted TSs and TRs: 36.141; 36.307
- 5229: Inter-band CA 3DL / Impacted TSs and TRs: LTE
- 5230: RP#65 completed / Impacted TSs and TRs: 36.101; 36.104; 36.133; generic 36.853 (3 Band CA with 1UL)
- 5231: RP#65 completed / Impacted TSs and TRs: 36.141; 36.307
- 5232: 3DL/1UL / Impacted TSs and TRs: LTE
- 5233: CD:Thu 11/12/14->Sun 15/03/15¦Compl:50%->70%¦Stat Rep: RP-141084->RP-141732 1st Apr 15: Compl:70%->100% 1st Apr 15: Stat Rep: RP-141732->RP-150013 / Impacted TSs and TRs: 36.101; 36.104; 36.133; generic 36.853 (3 Band CA with 1UL)
- 5234: CD:Thu 11/12/14->Tue 15/03/16¦Compl:50%->70%¦Stat Rep: RP-141084->RP-141732 1st Apr 15: Compl:70%->100% 1st Apr 15: CD:Tue 15/03/16->Sun 15/03/15 1st Apr 15: Stat Rep: RP-141732->RP-150013 / Impacted TSs and TRs: 36.141; 36.307

| ID | WBS | Task | Duration | Start | Finish | Complete | Baseline start | Baseline finish | Baseline duration | Constraint | Resources | Work | Actual work | Acronym | PCG approved | Impacted TSs and TRs | WI rapporteur name | WI rapporteur e-mail | Release | TSG approved | Special Focus Doc | Acronym_3GU_Export | Status Report | MCC resp |
| --- | --- | --- | --- | --- | --- | --- | --- | --- | --- | --- | --- | --- | --- | --- | --- | --- | --- | --- | --- | --- | --- | --- | --- | --- |
| 5235 | 1700.98 | **LTE Advanced 3 Band Carrier Aggregation (3DL/1UL) of Band 1, Band 42 and Band 42** | 66d? | 2014-06-16 A | 2014-09-12 A | 100% | 2014-06-13 | 2014-09-12 | 66d? |  | R4 | 1584h | 1584h | LTE_CA_B1_B42_B42 | 33 | LTE | NTT DOCOMO | ANDO Kei (kei.andou.ye@nttdocomo.com) | Rel-12 | 64 | CA | LTE_CA_B1_B42_B42 |  |  |
| 5236 | 1700.98.1 | Core part:LTE Advanced 3 Band Carrier Aggregation (3DL/1UL) of Band 1, Band 42 and Band 42 | 66d? | 2014-06-16 A | 2014-09-12 A | 100% | 2014-06-13 | 2014-09-12 | 66d? | finish no earlier than 2014-09-12 | R4 | 528h | 528h | LTE_CA_B1_B42_B42-Core | 33 | 36.101; 36.104; 36.133; generic 36.853 (3 Band CA with 1UL) | NTT DOCOMO | ANDO Kei (kei.andou.ye@nttdocomo.com) | Rel-12 | 64 | CA | LTE_CA_B1_B42_B42-Core | RP-141084 |  |
| 5237 | 1700.98.2 | Perf. Part:LTE Advanced 3 Band Carrier Aggregation (3DL/1UL) of Band 1, Band 42 and Band 42 | 66d? | 2014-06-16 A | 2014-09-12 A | 100% | 2014-06-13 | 2014-09-12 | 66d? | finish no earlier than 2014-09-12 | R4 | 528h | 528h | LTE_CA_B1_B42_B42-Perf | 33 | 36.141; 36.307 | NTT DOCOMO | ANDO Kei (kei.andou.ye@nttdocomo.com) | Rel-12 | 64 | CA | LTE_CA_B1_B42_B42-Perf | RP-141084 |  |
| 5238 | 1700.99 | **Additional bandwidth combination set for LTE Advanced intra-band contiguous Carrier Aggregation in Band 40 for 3DL** | 66d? | 2014-06-16 A | 2014-09-12 A | 100% | 2014-06-13 | 2014-09-12 | 66d? |  | R4 | 1096h | 1096h | LTE_CA_C_B40_3DL_BW | 33 | LTE | TeliaSonera | Ralf.Schuh@TeliaSonera.com | Rel-12 | 64 | CA | LTE_CA_C_B40_3DL_BW |  |  |
| 5239 | 1700.99.1 | Core part: Additional bandwidth combination set for LTE Advanced intra-band contiguous Carrier Aggregation in Band 40 for 3DL | 66d? | 2014-06-16 A | 2014-09-12 A | 100% | 2014-06-13 | 2014-09-12 | 66d? | finish no earlier than 2014-09-12 | R4 | 528h | 528h | LTE_CA_C_B40_3DL_BW-Core | 33 | 36.101 | TeliaSonera | Ralf.Schuh@TeliaSonera.com | Rel-12 | 64 | CA | LTE_CA_C_B40_3DL_BW-Core | RP-141084 |  |
| 5240 | 1700.99.2 | Perf. part: Additional bandwidth combination set for LTE Advanced intra-band contiguous Carrier Aggregation in Band 40 for 3DL | 5d? | 2014-09-08 A | 2014-09-12 A | 100% |  |  |  | finish no earlier than 2014-09-12 | R4 | 40h | 40h | LTE_CA_C_B40_3DL_BW-Perf | 33 | 36.307 | TeliaSonera | Ralf.Schuh@TeliaSonera.com | Rel-12 | 65 |  | LTE_CA_C_B40_3DL_BW-Perf | RP-141084 |  |
| 5241 | 1700.100 | **LTE Advanced inter-band Carrier Aggregation of Band 18 and Band 28** | 3d? | 2014-09-10 A | 2014-09-12 A | 100% | 2014-03-06 | 2015-03-13 | 267d? |  | R4 | 72h | 72h | LTE_CA_B18_B28 | 33 | LTE | KDDI | Masaaki Obara (ms-obara@kddi.com) | Rel-12 | 65 | CA | LTE_CA_B18_B28 |  | Issam |
| 5242 | 1700.100.1 | Core part:LTE Advanced inter-band Carrier Aggregation of Band 18 and Band 28 | 3d? | 2014-09-10 A | 2014-09-12 A | 100% | 2014-03-06 | 2015-03-13 | 267d? | finish no earlier than 2014-09-12 | R4 | 24h | 24h | LTE_CA_B18_B28-Core | 33 | 36.101; 36.104; 36.133 | KDDI | Masaaki Obara (ms-obara@kddi.com) | Rel-12 | 65 | CA | LTE_CA_B18_B28-Core |  | Issam |
| 5243 | 1700.100.2 | Perf. Part:LTE Advanced inter-band Carrier Aggregation of Band 18 and Band 28 | 3d? | 2014-09-10 A | 2014-09-12 A | 100% | 2014-03-06 | 2015-03-13 | 267d? | finish no earlier than 2014-09-12 | R4 | 24h | 24h | LTE_CA_B18_B28-Perf | 33 | 36.141; 36.307 | KDDI | Masaaki Obara (ms-obara@kddi.com) | Rel-12 | 65 | CA | LTE_CA_B18_B28-Perf |  | Issam |
| 5244 | 1700.101 | **LTE Advanced inter-band Carrier Aggregation of Band 5 and Band 13** | 206d? | 2014-03-06 A | 2014-12-15 A | 100% | 2014-03-06 | 2014-12-05 | 197d? |  | R4 | 4896h | 4896h | LTE_CA_B5_B13 | 32 | LTE | Intel | xinrong.wang@intel.com | Rel-12 | 63 | CA | LTE_CA_B5_B13 |  | Issam |
| 5245 | 1700.101.1 | Core part:LTE Advanced inter-band Carrier Aggregation of Band 5 and Band 13 | 203d? | 2014-03-06 A | 2014-12-15 A | 100% | 2014-03-06 | 2014-12-05 | 197d? | finish no earlier than 2014-12-15 | R4 | 1624h | 1624h | LTE_CA_B5_B13-Core | 32 | 36.101; 36.104; 36.133; generic 36.851 (2 Band CA with 1UL) | Intel | xinrong.wang@intel.com | Rel-12 | 63 | CA | LTE_CA_B5_B13-Core | RP-141732 | Issam |
| 5246 | 1700.101.2 | Perf. part:LTE Advanced inter-band Carrier Aggregation of Band 5 and Band 13 | 203d? | 2014-03-06 A | 2014-12-15 A | 100% | 2014-03-06 | 2014-12-05 | 197d? | finish no earlier than 2014-12-15 | R4 | 1624h | 1624h | LTE_CA_B5_B13-Perf | 32 | 36.101; 36.133; 36.141; 36.307 | Intel | xinrong.wang@intel.com | Rel-12 | 63 | CA | LTE_CA_B5_B13-Perf | RP-141732 | Issam |
| 5247 | 1700.102 | **LTE Advanced 3 Band Carrier Aggregation (3DL/1UL) of Band 2, Band 2 and Band 5** | 206d? | 2014-03-06 A | 2014-12-15 A | 100% | 2014-03-06 | 2014-12-05 | 197d? |  | R4 | 4912h | 4912h | LTE_CA_B2_B2_B5 | 32 | LTE | Intel | peiling.zhang@intel.com | Rel-12 | 63 | CA | LTE_CA_B2_B2_B5 |  | Issam |
| 5248 | 1700.102.1 | Core part:LTE Advanced 3 Band Carrier Aggregation (3DL/1UL) of Band 2, Band 2 and Band 5 | 205d? | 2014-03-06 A | 2014-12-15 A | 100% | 2014-03-06 | 2014-12-05 | 197d? | finish no earlier than 2014-12-15 | R4 | 1640h | 1640h | LTE_CA_B2_B2_B5-Core | 32 | 36.101; 36.104; 36.133; generic 36.853 (3 Band CA with 1UL) | Intel | peiling.zhang@intel.com | Rel-12 | 63 | CA | LTE_CA_B2_B2_B5-Core | RP-141732 | Issam |
| 5249 | 1700.102.2 | Perf. part:LTE Advanced 3 Band Carrier Aggregation (3DL/1UL) of Band 2, Band 2 and Band 5 | 203d? | 2014-03-06 A | 2014-12-15 A | 100% | 2014-03-06 | 2014-12-05 | 197d? | finish no earlier than 2014-12-15 | R4 | 1624h | 1624h | LTE_CA_B2_B2_B5-Perf | 32 | 36.101; 36.133; 36.141; 36.307 | Intel | peiling.zhang@intel.com | Rel-12 | 63 | CA | LTE_CA_B2_B2_B5-Perf | RP-141732 | Issam |
| 5250 | 1700.103 | **LTE Advanced 3 Band Carrier Aggregation (3DL/1UL) of Band 4, Band 4 and Band 5** | 206d? | 2014-03-06 A | 2014-12-15 A | 100% | 2014-03-06 | 2014-12-05 | 197d? |  | R4 | 4912h | 4912h | LTE_CA_B4_B4_B5 | 32 | LTE | Intel | peiling.zhang@intel.com | Rel-12 | 63 | CA | LTE_CA_B4_B4_B5 |  | Issam |
| 5251 | 1700.103.1 | Core part:LTE Advanced 3 Band Carrier Aggregation (3DL/1UL) of Band 4, Band 4 and Band 5 | 205d? | 2014-03-06 A | 2014-12-15 A | 100% | 2014-03-06 | 2014-12-05 | 197d? | finish no earlier than 2014-12-15 | R4 | 1640h | 1640h | LTE_CA_B4_B4_B5-Core | 32 | 36.101; 36.104; 36.133; generic 36.853 (3 Band CA with 1UL) | Intel | peiling.zhang@intel.com | Rel-12 | 63 | CA | LTE_CA_B4_B4_B5-Core | RP-141732 | Issam |
| 5252 | 1700.103.2 | Perf. part:LTE Advanced 3 Band Carrier Aggregation (3DL/1UL) of Band 4, Band 4 and Band 5 | 203d? | 2014-03-06 A | 2014-12-15 A | 100% | 2014-03-06 | 2014-12-05 | 197d? | finish no earlier than 2014-12-15 | R4 | 1624h | 1624h | LTE_CA_B4_B4_B5-Perf | 32 | 36.101; 36.133; 36.141; 36.307 | Intel | peiling.zhang@intel.com | Rel-12 | 63 | CA | LTE_CA_B4_B4_B5-Perf | RP-141732 | Issam |
| 5253 | 1700.104 | **LTE Advanced 3 Band Carrier Aggregation (3DL/1UL) of Band 2, Band 5 and Band 13** | 206d? | 2014-03-06 A | 2014-12-15 A | 100% | 2014-03-06 | 2014-12-05 | 197d? |  | R4 | 4896h | 4896h | LTE_CA_B2_B5_B13 | 32 | LTE | Intel | xinrong.wang@intel.com | Rel-12 | 63 | CA | LTE_CA_B2_B5_B13 |  | Issam |
| 5254 | 1700.104.1 | Core part:LTE Advanced 3 Band Carrier Aggregation (3DL/1UL) of Band 2, Band 5 and Band 13 | 203d? | 2014-03-06 A | 2014-12-15 A | 100% | 2014-03-06 | 2014-12-05 | 197d? | finish no earlier than 2014-12-15 | R4 | 1624h | 1624h | LTE_CA_B2_B5_B13-Core | 32 | 36.101; 36.104; 36.133; generic 36.853 (3 Band CA with 1UL) | Intel | xinrong.wang@intel.com | Rel-12 | 63 | CA | LTE_CA_B2_B5_B13-Core | RP-141732 | Issam |
| 5255 | 1700.104.2 | Perf. part:LTE Advanced 3 Band Carrier Aggregation (3DL/1UL) of Band 2, Band 5 and Band 13 | 203d? | 2014-03-06 A | 2014-12-15 A | 100% | 2014-03-06 | 2014-12-05 | 197d? | finish no earlier than 2014-12-15 | R4 | 1624h | 1624h | LTE_CA_B2_B5_B13-Perf | 32 | 36.101; 36.133; 36.141; 36.307 | Intel | xinrong.wang@intel.com | Rel-12 | 63 | CA | LTE_CA_B2_B5_B13-Perf | RP-141732 | Issam |
| 5256 | 1700.105 | **LTE Advanced 3 Band Carrier Aggregation (3DL/1UL) of Band 4, Band 5 and Band 13** | 206d? | 2014-03-06 A | 2014-12-15 A | 100% | 2014-03-06 | 2014-12-05 | 197d? |  | R4 | 4896h | 4896h | LTE_CA_B4_B5_B13 | 32 | LTE | Intel | xinrong.wang@intel.com | Rel-12 | 63 | CA | LTE_CA_B4_B5_B13 |  | Issam |
| 5257 | 1700.105.1 | Core part:LTE Advanced 3 Band Carrier Aggregation (3DL/1UL) of Band 4, Band 5 and Band 13 | 203d? | 2014-03-06 A | 2014-12-15 A | 100% | 2014-03-06 | 2014-12-05 | 197d? | finish no earlier than 2014-12-15 | R4 | 1624h | 1624h | LTE_CA_B4_B5_B13-Core | 32 | 36.101; 36.104; 36.133; generic 36.853 (3 Band CA with 1UL) | Intel | xinrong.wang@intel.com | Rel-12 | 63 | CA | LTE_CA_B4_B5_B13-Core | RP-141732 | Issam |
| 5258 | 1700.105.2 | Perf. part:LTE Advanced 3 Band Carrier Aggregation (3DL/1UL) of Band 4, Band 5 and Band 13 | 203d? | 2014-03-06 A | 2014-12-15 A | 100% | 2014-03-06 | 2014-12-05 | 197d? | finish no earlier than 2014-12-15 | R4 | 1624h | 1624h | LTE_CA_B4_B5_B13-Perf | 32 | 36.101; 36.133; 36.141; 36.307 | Intel | xinrong.wang@intel.com | Rel-12 | 63 | CA | LTE_CA_B4_B5_B13-Perf | RP-141732 | Issam |

Notes:
- 5235: Inter-band CA 3DL
- 5236: RP#65 completed
- 5237: RP#65 completed
- 5238: Inter-band CA 3DL
- 5239: RP#65 completed. Updated WID RP-140950=>RP-141127
- 5240: RP#65 updated WID RP-140950=>RP-141127 (added Perf. Part). Completed.
- 5241: Inter-band CA 2DL
- 5242: RP#65 WID approved & completed. Triggered by revised Rel-13 WID RP-140451=>RP-141610 (take out B18_B28 for Rel-12 from the Rel-13 B1_B18_B28)
- 5243: -
- 5244: Inter-band CA 2DL
- 5245: CD:Thu 12/03/15->Mon 15/12/14¦Compl:50%->100%¦Stat Rep: RP-141084->RP-141732¦Release: Rel-13->Rel-12
- 5246: CD:Thu 12/03/15->Mon 15/12/14¦Compl:10%->100%¦Stat Rep: RP-141084->RP-141732¦Release: Rel-13->Rel-12
- 5247: Inter-band CA 3DL
- 5248: CD:Thu 12/03/15->Mon 15/12/14¦Compl:90%->100%¦Stat Rep: RP-141084->RP-141732¦Release: Rel-13->Rel-12
- 5249: CD:Thu 12/03/15->Mon 15/12/14¦Compl:10%->100%¦Stat Rep: RP-141084->RP-141732¦Release: Rel-13->Rel-12
- 5250: Inter-band CA 3DL
- 5251: CD:Thu 12/03/15->Mon 15/12/14¦Compl:90%->100%¦Stat Rep: RP-141084->RP-141732¦Release: Rel-13->Rel-12
- 5252: CD:Thu 12/03/15->Mon 15/12/14¦Compl:10%->100%¦Stat Rep: RP-141084->RP-141732¦Release: Rel-13->Rel-12
- 5253: Inter-band CA 3DL
- 5254: CD:Thu 12/03/15->Mon 15/12/14¦Compl:50%->100%¦Stat Rep: RP-141084->RP-141732¦Release: Rel-13->Rel-12
- 5255: CD:Thu 12/03/15->Mon 15/12/14¦Compl:10%->100%¦Stat Rep: RP-141084->RP-141732¦Release: Rel-13->Rel-12
- 5256: Inter-band CA 3DL
- 5257: CD:Thu 12/03/15->Mon 15/12/14¦Compl:50%->100%¦Stat Rep: RP-141084->RP-141732¦Release: Rel-13->Rel-12
- 5258: CD:Thu 12/03/15->Mon 15/12/14¦Compl:10%->100%¦Stat Rep: RP-141084->RP-141732¦Release: Rel-13->Rel-12

| ID | WBS | Task | Duration | Start | Finish | Complete | Baseline start | Baseline finish | Baseline duration | Constraint | Resources | Work | Actual work | Acronym | PCG approved | WI rapporteur name | WI rapporteur e-mail | Release | TSG approved | MCC resp | Special Focus Doc | Acronym_3GU_Export | Status Report |
| --- | --- | --- | --- | --- | --- | --- | --- | --- | --- | --- | --- | --- | --- | --- | --- | --- | --- | --- | --- | --- | --- | --- | --- |
| 5259 | 1700.106 | **LTE Advanced 3 Band Carrier Aggregation (3DL/1UL) of Band 1, Band 3 and Band 26** | 206d? | 2014-03-06 A | 2014-12-15 A | 100% | 2014-03-06 | 2014-12-05 | 197d? |  | R4 | 4896h | 4896h | LTE_CA_B1_B3_B26 | 32 | China Telecom | Zhao Dong (zhaodong@ctbri.com.cn) | Rel-12 | 63 | Issam | CA | LTE_CA_B1_B3_B26 |  |
| 5260 | 1700.106.1 | Core part:LTE Advanced 3 Band Carrier Aggregation (3DL/1UL) of Band 1, Band 3 and Band 26 | 203d? | 2014-03-06 A | 2014-12-15 A | 100% | 2014-03-06 | 2014-12-05 | 197d? | finish no earlier than 2014-12-15 | R4 | 1624h | 1624h | LTE_CA_B1_B3_B26-Core | 32 | China Telecom | Zhao Dong (zhaodong@ctbri.com.cn) | Rel-12 | 63 | Issam | CA | LTE_CA_B1_B3_B26-Core | RP-141732 |
| 5261 | 1700.106.2 | Perf. part:LTE Advanced 3 Band Carrier Aggregation (3DL/1UL) of Band 1, Band 3 and Band 26 | 203d? | 2014-03-06 A | 2014-12-15 A | 100% | 2014-03-06 | 2014-12-05 | 197d? | finish no earlier than 2014-12-15 | R4 | 1624h | 1624h | LTE_CA_B1_B3_B26-Perf | 32 | China Telecom | Zhao Dong (zhaodong@ctbri.com.cn) | Rel-12 | 63 | Issam | CA | LTE_CA_B1_B3_B26-Perf | RP-141732 |
| 5262 | 1700.107 | **LTE Advanced 3 Band Carrier Aggregation (3DL/1UL) of Band 1, Band 18 and Band 28** | 206d? | 2014-03-06 A | 2014-12-15 A | 100% | 2014-03-06 | 2015-03-13 | 267d? |  | R4 | 4896h | 4896h | LTE_CA_B1_B18_B28 | 32 | KDDI | Masaaki Obara (ms-obara@kddi.com) | Rel-12 | 63 | Issam | CA | LTE_CA_B1_B18_B28 |  |
| 5263 | 1700.107.1 | Core part:LTE Advanced 3 Band Carrier Aggregation (3DL/1UL) of Band 1, Band 18 and Band 28 | 203d? | 2014-03-06 A | 2014-12-15 A | 100% | 2014-03-06 | 2015-03-13 | 267d? | finish no earlier than 2014-12-15 | R4 | 1624h | 1624h | LTE_CA_B1_B18_B28-Core | 32 | KDDI | Masaaki Obara (ms-obara@kddi.com) | Rel-12 | 63 | Issam | CA | LTE_CA_B1_B18_B28-Core | RP-141732 |
| 5264 | 1700.107.2 | Perf. part:LTE Advanced 3 Band Carrier Aggregation (3DL/1UL) of Band 1, Band 18 and Band 28 | 203d? | 2014-03-11 A | 2014-12-15 A | 100% | 2014-03-06 | 2015-03-13 | 267d? | finish no earlier than 2014-12-15 | R4 | 1624h | 1624h | LTE_CA_B1_B18_B28-Perf | 32 | KDDI | Masaaki Obara (ms-obara@kddi.com) | Rel-12 | 63 | Issam | CA | LTE_CA_B1_B18_B28-Perf | RP-141732 |
| 5265 | 1700.108 | **LTE Advanced 3 Band Carrier Aggregation (3DL/1UL) of Band 4, Band 7 and Band 12** | 132d? | 2014-06-18 A | 2014-12-15 A | 100% | 2014-06-13 | 2015-03-13 | 196d? |  | R4 | 3168h | 3168h | LTE_CA_B4_B7_B12 | 33 | Rogers Wireless | pavlo.nebesny@rci.rogers.com | Rel-12 | 64 |  | CA | LTE_CA_B4_B7_B12 |  |
| 5266 | 1700.108.1 | Core part:LTE Advanced 3 Band Carrier Aggregation (3DL/1UL) of Band 4, Band 7 and Band 12 | 132d? | 2014-06-18 A | 2014-12-15 A | 100% | 2014-06-13 | 2015-03-13 | 196d? | finish no earlier than 2014-12-15 | R4 | 1056h | 1056h | LTE_CA_B4_B7_B12-Core | 33 | Rogers Wireless | pavlo.nebesny@rci.rogers.com | Rel-12 | 64 |  | CA | LTE_CA_B4_B7_B12-Core | RP-141732 |
| 5267 | 1700.108.2 | Perf. Part:LTE Advanced 3 Band Carrier Aggregation (3DL/1UL) of Band 4, Band 7 and Band 12 | 132d? | 2014-06-18 A | 2014-12-15 A | 100% | 2014-06-13 | 2015-03-13 | 196d? | finish no earlier than 2014-12-15 | R4 | 1056h | 1056h | LTE_CA_B4_B7_B12-Perf | 33 | Rogers Wireless | pavlo.nebesny@rci.rogers.com | Rel-12 | 64 |  | CA | LTE_CA_B4_B7_B12-Perf | RP-141732 |
| 5268 | 1700.109 | **LTE Advanced 3 Band Carrier Aggregation (3DL/1UL) of Band 4, Band 4 and Band 7** | 132d? | 2014-06-18 A | 2014-12-15 A | 100% | 2014-06-13 | 2015-03-13 | 196d? |  | R4 | 3168h | 3168h | LTE_CA_B4_B4_B7 | 33 | Rogers Wireless | pavlo.nebesny@rci.rogers.com | Rel-12 | 64 |  | CA | LTE_CA_B4_B4_B7 |  |
| 5269 | 1700.109.1 | Core part:LTE Advanced 3 Band Carrier Aggregation (3DL/1UL) of Band 4, Band 4 and Band 7 | 132d? | 2014-06-18 A | 2014-12-15 A | 100% | 2014-06-13 | 2015-03-13 | 196d? | finish no earlier than 2014-12-15 | R4 | 1056h | 1056h | LTE_CA_B4_B4_B7-Core | 33 | Rogers Wireless | pavlo.nebesny@rci.rogers.com | Rel-12 | 64 |  | CA | LTE_CA_B4_B4_B7-Core | RP-141732 |
| 5270 | 1700.109.2 | Perf. Part:LTE Advanced 3 Band Carrier Aggregation (3DL/1UL) of Band 4, Band 4 and Band 7 | 132d? | 2014-06-18 A | 2014-12-15 A | 100% | 2014-06-13 | 2015-03-13 | 196d? | finish no earlier than 2014-12-15 | R4 | 1056h | 1056h | LTE_CA_B4_B4_B7-Perf | 33 | Rogers Wireless | pavlo.nebesny@rci.rogers.com | Rel-12 | 64 |  | CA | LTE_CA_B4_B4_B7-Perf | RP-141732 |
| 5271 | 1700.110 | **LTE Advanced 3 Band Carrier Aggregation (3DL/1UL) of Band 39, Band 41 and Band 41** | 134d? | 2014-06-16 A | 2014-12-15 A | 100% | 2014-06-13 | 2014-12-05 | 126d? |  | R4 | 3184h | 3184h | LTE_CA_B39_B41_B41 | 33 | China Mobile | PAN Qun (panqun@chinamobile.com) | Rel-12 | 64 |  | CA | LTE_CA_B39_B41_B41 |  |
| 5272 | 1700.110.1 | Core part:LTE Advanced 3 Band Carrier Aggregation (3DL/1UL) of Band 39, Band 41 and Band 41 | 132d? | 2014-06-16 A | 2014-12-15 A | 100% | 2014-06-13 | 2014-12-05 | 126d? | finish no earlier than 2014-12-15 | R4 | 1056h | 1056h | LTE_CA_B39_B41_B41-Core | 33 | China Mobile | PAN Qun (panqun@chinamobile.com) | Rel-12 | 64 |  | CA | LTE_CA_B39_B41_B41-Core | RP-141732 |
| 5273 | 1700.110.2 | Perf. Part:LTE Advanced 3 Band Carrier Aggregation (3DL/1UL) of Band 39, Band 41 and Band 41 | 132d? | 2014-06-18 A | 2014-12-15 A | 100% | 2014-06-13 | 2014-12-05 | 126d? | finish no earlier than 2014-12-15 | R4 | 1056h | 1056h | LTE_CA_B39_B41_B41-Perf | 33 | China Mobile | PAN Qun (panqun@chinamobile.com) | Rel-12 | 64 |  | CA | LTE_CA_B39_B41_B41-Perf | RP-141732 |
| 5274 | 1700.111 | **LTE Advanced 3 Band Carrier Aggregation (3DL/1UL) of Band 1, Band 41 and Band 41** | 132d? | 2014-06-18 A | 2014-12-15 A | 100% | 2014-06-13 | 2015-03-13 | 196d? |  | R4 | 3168h | 3168h | LTE_CA_B1_B41_B41 | 33 | KDDI | Masaaki Obara (ms-obara@kddi.com) | Rel-12 | 64 |  | CA | LTE_CA_B1_B41_B41 |  |
| 5275 | 1700.111.1 | Core part:LTE Advanced 3 Band Carrier Aggregation (3DL/1UL) of Band 1, Band 41 and Band 41 | 132d? | 2014-06-18 A | 2014-12-15 A | 100% | 2014-06-13 | 2015-03-13 | 196d? | finish no earlier than 2014-12-15 | R4 | 1056h | 1056h | LTE_CA_B1_B41_B41-Core | 33 | KDDI | Masaaki Obara (ms-obara@kddi.com) | Rel-12 | 64 |  | CA | LTE_CA_B1_B41_B41-Core | RP-141732 |
| 5276 | 1700.111.2 | Perf. Part:LTE Advanced 3 Band Carrier Aggregation (3DL/1UL) of Band 1, Band 41 and Band 41 | 132d? | 2014-06-18 A | 2014-12-15 A | 100% | 2014-06-13 | 2015-03-13 | 196d? | finish no earlier than 2014-12-15 | R4 | 1056h | 1056h | LTE_CA_B1_B41_B41-Perf | 33 | KDDI | Masaaki Obara (ms-obara@kddi.com) | Rel-12 | 64 |  | CA | LTE_CA_B1_B41_B41-Perf | RP-141732 |
| 5277 | 1700.112 | **LTE Advanced 3 Band Carrier Aggregation (3DL/1UL) of Band 26, Band 41 and Band 41** | 132d? | 2014-06-18 A | 2014-12-15 A | 100% | 2014-06-13 | 2015-03-13 | 196d? |  | R4 | 3168h | 3168h | LTE_CA_B26_B41_B41 | 33 | KDDI | Masaaki Obara (ms-obara@kddi.com) | Rel-12 | 64 |  | CA | LTE_CA_B26_B41_B41 |  |
| 5278 | 1700.112.1 | Core part:LTE Advanced 3 Band Carrier Aggregation (3DL/1UL) of Band 26, Band 41 and Band 41 | 132d? | 2014-06-18 A | 2014-12-15 A | 100% | 2014-06-13 | 2015-03-13 | 196d? | finish no earlier than 2014-12-15 | R4 | 1056h | 1056h | LTE_CA_B26_B41_B41-Core | 33 | KDDI | Masaaki Obara (ms-obara@kddi.com) | Rel-12 | 64 |  | CA | LTE_CA_B26_B41_B41-Core | RP-141732 |
| 5279 | 1700.112.2 | Perf. Part:LTE Advanced 3 Band Carrier Aggregation (3DL/1UL) of Band 26, Band 41 and Band 41 | 132d? | 2014-06-18 A | 2014-12-15 A | 100% | 2014-06-13 | 2015-03-13 | 196d? | finish no earlier than 2014-12-15 | R4 | 1056h | 1056h | LTE_CA_B26_B41_B41-Perf | 33 | KDDI | Masaaki Obara (ms-obara@kddi.com) | Rel-12 | 64 |  | CA | LTE_CA_B26_B41_B41-Perf | RP-141732 |
| 5280 | 1700.113 | **LTE Advanced 3 Band Carrier Aggregation (3DL/1UL) of Band 25, Band 41 and Band 41** | 68d? | 2014-09-15 A | 2014-12-15 A | 100% | 2014-06-13 | 2015-03-13 | 196d? |  | R4 | 1632h | 1632h | LTE_CA_B25_B41_B41 | 33 | Alcatel-Lucent | Ng, Man Hung (man-hung.ng@alcatel-lucent.com) | Rel-12 | 65 |  | CA | LTE_CA_B25_B41_B41 |  |
| 5281 | 1700.113.1 | Core part:LTE Advanced 3 Band Carrier Aggregation (3DL/1UL) of Band 25, Band 41 and Band 41 | 68d? | 2014-09-15 A | 2014-12-15 A | 100% | 2014-06-13 | 2015-03-13 | 196d? | finish no earlier than 2014-12-15 | R4 | 544h | 544h | LTE_CA_B25_B41_B41-Core | 33 | Alcatel-Lucent | Ng, Man Hung (man-hung.ng@alcatel-lucent.com) | Rel-12 | 65 |  | CA | LTE_CA_B25_B41_B41-Core | RP-141732 |
| 5282 | 1700.113.2 | Perf. Part:LTE Advanced 3 Band Carrier Aggregation (3DL/1UL) of Band 25, Band 41 and Band 41 | 68d? | 2014-09-15 A | 2014-12-15 A | 100% | 2014-06-13 | 2015-03-13 | 196d? | finish no earlier than 2014-12-15 | R4 | 544h | 544h | LTE_CA_B25_B41_B41-Perf | 33 | Alcatel-Lucent | Ng, Man Hung (man-hung.ng@alcatel-lucent.com) | Rel-12 | 65 |  | CA | LTE_CA_B25_B41_B41-Perf | RP-141732 |

Notes:
- 5259: Inter-band CA 3DL / Impacted TSs and TRs: LTE
- 5260: CD:Thu 11/12/14->Mon 15/12/14¦Compl:90%->100%¦Stat Rep: RP-141084->RP-141732¦Release: Rel-13->Rel-12 / Impacted TSs and TRs: 36.101; 36.104; 36.133; generic 36.853 (3 Band CA with 1UL)
- 5261: CD:Thu 11/12/14->Mon 15/12/14¦Compl:90%->100%¦Stat Rep: RP-141084->RP-141732¦Release: Rel-13->Rel-12 / Impacted TSs and TRs: 36.141; 36.307
- 5262: Inter-band CA 3DL / Impacted TSs and TRs: LTE
- 5263: ¦WID: RP-142043->RP-141788¦Stat Rep: RP-141084->RP-141732¦Release: Rel-13->Rel-12 / Impacted TSs and TRs: 36.101; 36.104; 36.133; generic 36.853 (3 Band CA with 1UL)
- 5264: ¦WID: RP-142043->RP-141788¦Stat Rep: RP-141084->RP-141732¦Release: Rel-13->Rel-12 / Impacted TSs and TRs: 36.141; 36.307
- 5265: Inter-band CA 3DL/1UL / Impacted TSs and TRs: LTE
- 5266: CD:Thu 12/03/15->Mon 15/12/14¦Compl:0%->100%¦Stat Rep: RP-141084->RP-141732¦Release: Rel-13->Rel-12 / Impacted TSs and TRs: 36.101; 36.104; 36.133; 36.307; generic 36.851 (2 Band CA with 1UL); generic 36.853 (3 Band CA with 1UL)
- 5267: CD:Thu 12/03/15->Mon 15/12/14¦Compl:0%->100%¦Stat Rep: RP-141084->RP-141732¦Release: Rel-13->Rel-12 / Impacted TSs and TRs: 36.133; 36.141
- 5268: Inter-band CA 3DL/1UL / Impacted TSs and TRs: LTE
- 5269: CD:Thu 12/03/15->Mon 15/12/14¦Compl:0%->100%¦Stat Rep: RP-141084->RP-141732¦Release: Rel-13->Rel-12 / Impacted TSs and TRs: 36.101; 36.104; 36.133; 36.307; generic 36.853 (3 Band CA with 1UL)
- 5270: CD:Thu 12/03/15->Mon 15/12/14¦Compl:0%->100%¦Stat Rep: RP-141084->RP-141732¦Release: Rel-13->Rel-12 / Impacted TSs and TRs: 36.133; 36.141
- 5271: Inter-band CA 3DL/1UL / Impacted TSs and TRs: LTE
- 5272: ¦WID: RP-140708->RP-142301¦Stat Rep: RP-141084->RP-141732¦Release: Rel-13->Rel-12 / Impacted TSs and TRs: 36.101; 36.104; 36.133; generic 36.853 (3 Band CA with 1UL)
- 5273: ¦WID: RP-140708->RP-142301¦Stat Rep: RP-141084->RP-141732¦Release: Rel-13->Rel-12 / Impacted TSs and TRs: 36.141; 36.307
- 5274: Inter-band CA 3DL/1UL / Impacted TSs and TRs: LTE
- 5275: ¦WID: RP-142043->RP-142297¦Stat Rep: RP-141084->RP-141732¦Release: Rel-13->Rel-12 / Impacted TSs and TRs: 36.101; 36.104; 36.133; generic 36.853 (3 Band CA with 1UL)
- 5276: Compl:100%->0%¦WID: RP-142043->RP-142297¦Stat Rep: RP-141084->RP-141732¦Release: Rel-13->Rel-12 / Impacted TSs and TRs: 36.141; 36.307
- 5277: Inter-band CA 3DL/1UL / Impacted TSs and TRs: LTE
- 5278: ¦WID: RP-142043->RP-142298¦Stat Rep: RP-141084->RP-141732¦Release: Rel-13->Rel-12 / Impacted TSs and TRs: 36.101; 36.104; 36.133; generic 36.853 (3 Band CA with 1UL)
- 5279: Compl:100%->0%¦WID: RP-142043->RP-142298¦Stat Rep: RP-141084->RP-141732¦Release: Rel-13->Rel-12 / Impacted TSs and TRs: 36.141; 36.307
- 5280: Inter-band CA 3DL/1UL / Impacted TSs and TRs: LTE
- 5281: ¦WID: RP-142043->RP-142018¦Stat Rep: -->RP-141732¦Release: Rel-13->Rel-12 / Impacted TSs and TRs: 36.101; 36.104; 36.307; New 36.833-x-yz
- 5282: ¦WID: RP-142043->RP-142018¦Stat Rep: -->RP-141732¦Release: Rel-13->Rel-12 / Impacted TSs and TRs: 36.141

| ID | WBS | Task | Duration | Start | Finish | Complete | Baseline start | Baseline finish | Baseline duration | Constraint | Resources | Work | Actual work | Acronym | PCG approved | WI rapporteur name | WI rapporteur e-mail | Release | TSG approved | Special Focus Doc | Acronym_3GU_Export | Status Report | MCC resp | PCG stopped | TSG stopped |
| --- | --- | --- | --- | --- | --- | --- | --- | --- | --- | --- | --- | --- | --- | --- | --- | --- | --- | --- | --- | --- | --- | --- | --- | --- | --- |
| 5283 | 1700.114 | **LTE Advanced 3 Band Carrier Aggregation (3DL/1UL) of Band 39, Band 39 and Band 41** | 68d? | 2014-09-15 A | 2014-12-15 A | 100% | 2014-06-13 | 2015-03-13 | 196d? |  | R4 | 1632h | 1632h | LTE_CA_B39_B39_B41 | 33 | China Mobile | PAN, Qun (panqun@chinamobile.com) | Rel-12 | 65 | CA | LTE_CA_B39_B39_B41 |  |  |  |  |
| 5284 | 1700.114.1 | Core part:LTE Advanced 3 Band Carrier Aggregation (3DL/1UL) of Band 39, Band 39 and Band 41 | 68d? | 2014-09-15 A | 2014-12-15 A | 100% | 2014-06-13 | 2015-03-13 | 196d? | finish no earlier than 2014-12-15 | R4 | 544h | 544h | LTE_CA_B39_B39_B41-Core | 33 | China Mobile | PAN, Qun (panqun@chinamobile.com) | Rel-12 | 65 | CA | LTE_CA_B39_B39_B41-Core | RP-141732 |  |  |  |
| 5285 | 1700.114.2 | Perf. Part:LTE Advanced 3 Band Carrier Aggregation (3DL/1UL) of Band 39, Band 39 and Band 41 | 68d? | 2014-09-15 A | 2014-12-15 A | 100% | 2014-06-13 | 2015-03-13 | 196d? | finish no earlier than 2014-12-15 | R4 | 544h | 544h | LTE_CA_B39_B39_B41-Perf | 33 | China Mobile | PAN, Qun (panqun@chinamobile.com) | Rel-12 | 65 | CA | LTE_CA_B39_B39_B41-Perf | RP-141732 |  |  |  |
| 5286 | 1700.115 | **LTE Advanced 3 Band Carrier Aggregation (3DL/1UL) of Band 2, Band 2 and Band 29** | 68d? | 2014-09-15 A | 2014-12-15 A | 100% | 2014-06-13 | 2015-03-13 | 196d? |  | R4 | 1632h | 1632h | LTE_CA_B2_B2_B29 | 33 | AT&T | marc.grant@att.com | Rel-12 | 65 | CA | LTE_CA_B2_B2_B29 |  |  |  |  |
| 5287 | 1700.115.1 | Core part:LTE Advanced 3 Band Carrier Aggregation (3DL/1UL) of Band 2, Band 2 and Band 29 | 68d? | 2014-09-15 A | 2014-12-15 A | 100% | 2014-06-13 | 2015-03-13 | 196d? | finish no earlier than 2014-12-15 | R4 | 544h | 544h | LTE_CA_B2_B2_B29-Core | 33 | AT&T | marc.grant@att.com | Rel-12 | 65 | CA | LTE_CA_B2_B2_B29-Core | RP-141732 |  |  |  |
| 5288 | 1700.115.2 | Perf. Part:LTE Advanced 3 Band Carrier Aggregation (3DL/1UL) of Band 2, Band 2 and Band 29 | 68d? | 2014-09-15 A | 2014-12-15 A | 100% | 2014-06-13 | 2015-03-13 | 196d? | finish no earlier than 2014-12-15 | R4 | 544h | 544h | LTE_CA_B2_B2_B29-Perf | 33 | AT&T | marc.grant@att.com | Rel-12 | 65 | CA | LTE_CA_B2_B2_B29-Perf | RP-141732 |  |  |  |
| 5289 | 1700.116 | **LTE Advanced 3 Band Carrier Aggregation (3DL/1UL) of Band 2, Band 4 and Band 29** | 68d? | 2014-09-15 A | 2014-12-15 A | 100% | 2014-06-13 | 2015-03-13 | 196d? |  | R4 | 1632h | 1632h | LTE_CA_B2_B4_B29 | 33 | Huawei | SHAN Huiping (shanhuiping@huawei.com) | Rel-12 | 65 | CA | LTE_CA_B2_B4_B29 |  |  |  |  |
| 5290 | 1700.116.1 | Core part:LTE Advanced 3 Band Carrier Aggregation (3DL/1UL) of Band 2, Band 4 and Band 29 | 68d? | 2014-09-15 A | 2014-12-15 A | 100% | 2014-06-13 | 2015-03-13 | 196d? | finish no earlier than 2014-12-15 | R4 | 544h | 544h | LTE_CA_B2_B4_B29-Core | 33 | Huawei | SHAN Huiping (shanhuiping@huawei.com) | Rel-12 | 65 | CA | LTE_CA_B2_B4_B29-Core | RP-141732 |  |  |  |
| 5291 | 1700.116.2 | Perf. Part:LTE Advanced 3 Band Carrier Aggregation (3DL/1UL) of Band 2, Band 4 and Band 29 | 68d? | 2014-09-15 A | 2014-12-15 A | 100% | 2014-06-13 | 2015-03-13 | 196d? | finish no earlier than 2014-12-15 | R4 | 544h | 544h | LTE_CA_B2_B4_B29-Perf | 33 | Huawei | SHAN Huiping (shanhuiping@huawei.com) | Rel-12 | 65 | CA | LTE_CA_B2_B4_B29-Perf | RP-141732 |  |  |  |
| 5292 | 1701 | UE Conformance Test Aspects – Further Rel-12 configurations for LTE Advanced Carrier Aggregation | 393d? | 2013-09-15 A | 2015-03-13 A | 100% | 2013-09-09 | 2014-12-05 | 327d? | finish no earlier than 2015-03-15 | R5 | 3144h | 3144h | LTE_CA_Rel12-UEConTest | 31 | Microsoft | jussi.kuusisto@microsoft.com | Rel-12 | 61 | CA | LTE_CA_Rel12-UEConTest | RP-150076 | Ingbert |  |  |
| 5293 | 1702 | UE Conformance Test Aspects – Further Rel-12 configurations for LTE Advanced Carrier Aggregation with 3DL | 394d? | 2014-09-15 A | 2016-03-15 A | 100% |  |  |  | finish no earlier than 2016-03-15 | R5 | 3152h | 3152h | LTE_CA_Rel12_3DL-UEConTest | 33 | Microsoft | jussi.kuusisto@microsoft.com | Rel-12 | 65 | CA | LTE_CA_Rel12_3DL-UEConTest | RP-151464 |  |  |  |
| 5294 | 1703 | **Deleted - Carrier based HetNet ICIC for LTE** | 595d? | 2011-03-18 A | 2013-06-14 A | 100% | 2011-03-18 | 2013-06-14 | 595d? |  | R3; R1; R2 | 28560h | 28560h | LTE_CA_HetNet_ICIC | 26 | Nokia Siemens Networks | krzysztof.kordybach@nsn.com | Rel-12 | 51 |  | LTE_CA_HetNet_ICIC |  | Juha | PCG-31 | RP-60 |
| 5295 | 1703.1 | Deleted - Core part: Carrier based HetNet ICIC for LTE | 595d? | 2011-03-18 A | 2013-06-14 A | 100% | 2011-03-18 | 2013-06-14 | 595d? | finish no earlier than 2013-06-14 | R3; R1; R2 | 14280h | 14280h | LTE_CA_HetNet_ICIC-Core | 26 | Nokia Siemens Networks | krzysztof.kordybach@nsn.com | Rel-12 | 51 |  | LTE_CA_HetNet_ICIC-Core | RP-130500 | Juha | PCG-31 | RP-60 |
| 5296 | 1704 | **LTE in the US Wireless Communications Service (WCS) Band 30** | 600d? | 2012-09-12 A | 2014-12-15 A | 100% | 2012-09-12 | 2014-12-05 | 591d? |  | R4; R2; R5 | 20312h | 20312h | LTE_WCS_band | 29 | AT&T | marc.grant@att.com | Rel-12 | 57 |  | LTE_WCS_band |  | Issam |  |  |
| 5297 | 1704.1 | Core part: LTE in the US Wireless Communications Service (WCS) Band 30 | 202d? | 2012-09-12 A | 2013-06-14 A | 100% | 2012-09-12 | 2013-06-14 | 202d? | finish no earlier than 2013-06-14 | R4; R2 | 3232h | 3232h | LTE_WCS_band-Core | 29 | AT&T | marc.grant@att.com | Rel-12 | 57 |  | LTE_WCS_band-Core | RP-130569 | Issam |  |  |
| 5298 | 1704.2 | Perf. Part: LTE in the US Wireless Communications Service (WCS) Band 30 | 201d? | 2012-09-13 A | 2013-06-14 A | 100% | 2012-09-13 | 2013-06-14 | 201d? | finish no earlier than 2013-06-14 | R4 | 1608h | 1608h | LTE_WCS_band-Perf | 29 | AT&T | marc.grant@att.com | Rel-12 | 57 |  | LTE_WCS_band-Perf | RP-130570 | Issam |  |  |
| 5299 | 1704.3 | Test Part: LTE in the US Wireless Communications Service (WCS) Band 30 | 134d? | 2014-06-15 A | 2014-12-15 A | 100% | 2014-06-13 | 2014-12-05 | 126d? | finish no earlier than 2014-12-15 | R5 | 1072h | 1072h | LTE_WCS_band-UEConTest | 33 | Ericsson | fredrik.sundstrom@ericsson.com | Rel-12 | 64 |  | LTE_WCS_band-UEConTest | RP-141773 |  |  |  |
| 5300 | 1705 | **Introduction of LTE 450 MHz band in Brazil** | 331d? | 2012-09-11 A | 2013-12-06 A | 100% | 2012-09-11 | 2013-12-06 | 331d? |  | R4; R5 | 10000h | 10000h | LTE450_Brazil | 29 | Huawei | Liehai Liu (liuliehai@huawei.com) | Rel-12 | 57 |  | LTE450_Brazil |  | Issam |  |  |
| 5301 | 1705.1 | Core part: Introduction of LTE 450 MHz band in Brazil | 201d? | 2012-09-11 A | 2013-06-14 A | 100% | 2012-09-11 | 2013-06-14 | 201d? | finish no earlier than 2013-06-14 | R4 | 1608h | 1608h | LTE450_Brazil-Core | 29 | Huawei | Liehai Liu (liuliehai@huawei.com) | Rel-12 | 57 |  | LTE450_Brazil-Core | RP-130567 | Issam |  |  |
| 5302 | 1705.2 | Perf. part: Introduction of LTE 450 MHz band in Brazil | 261d? | 2012-09-13 A | 2013-09-06 A | 100% | 2012-09-13 | 2013-09-06 | 261d? | finish no earlier than 2013-09-06 | R4 | 2088h | 2088h | LTE450_Brazil-Perf | 29 | Huawei | Liehai Liu (liuliehai@huawei.com) | Rel-12 | 57 |  | LTE450_Brazil-Perf | RP-131070 | Issam |  |  |
| 5303 | 1705.3 | Test part: Introduction of LTE 450 MHz band in Brazil | 126d? | 2013-06-18 A | 2013-12-06 A | 100% | 2013-06-18 | 2013-12-06 | 126d? | finish no earlier than 2013-12-06 | R5 | 1008h | 1008h | LTE450_Brazil-UEConTest | 31 | Huawei | Xiang Li (tricia.li@huawei.com) | Rel-12 | 60 |  | LTE450_Brazil-UEConTest | RP-131457 | Ingbert |  |  |
| 5304 | 1706 | **Further Downlink MIMO Enhancement for LTE Advanced** | 927d? | 2012-09-11 A | 2016-03-15 A | 100% | 2012-09-11 | 2014-09-12 | 532d? |  | R1; R4 | 25384.8h | 25384.8h | LTE_eDL_MIMO_enh | 29 | Alcatel-Lucent | Min Zhang (min.hs.zhang@alcatel-lucent.com) | Rel-12 | 57 |  | LTE_eDL_MIMO_enh |  | Patrick |  |  |
| 5305 | 1706.1 | Core part: Further Downlink MIMO Enhancement for LTE Advanced | 464d? | 2012-09-11 A | 2014-06-13 A | 100% | 2012-09-11 | 2014-06-13 | 464d? | finish no earlier than 2014-06-13 | R1 | 3696.76h | 3696.76h | LTE_eDL_MIMO_enh-Core | 29 | Alcatel-Lucent | Min Zhang (min.hs.zhang@alcatel-lucent.com) | Rel-12 | 57 |  | LTE_eDL_MIMO_enh-Core | RP-140652 | Patrick |  |  |
| 5306 | 1706.2 | Perf. part: Further Downlink MIMO Enhancement for LTE Advanced | 595d? | 2012-09-15 A | 2014-12-15 A | 100% | 2012-09-18 | 2014-09-12 | 526d? | finish no earlier than 2014-12-15 | R4 | 4760h | 4760h | LTE_eDL_MIMO_enh-Perf | 29 | Alcatel-Lucent | ren.da@alcatel-lucent.com | Rel-12 | 57 |  | LTE_eDL_MIMO_enh-Perf | RP-142042 | Issam |  |  |
| 5307 | 1706.3 | UE Conformance Test Aspects - Further DL MIMO Enhancement for LTE-Advanced | 262d? | 2015-03-16 A | 2016-03-15 A | 100% |  |  |  | finish no earlier than 2016-03-15 | R5 | 2096h | 2096h | LTE_eDL_MIMO_enh-UEConTest | 34 | ZTE |  | Rel-12 | 67 |  |  | RP-151189 |  |  |  |

Notes:
- 5283: Inter-band CA 3DL/1UL / Impacted TSs and TRs: LTE
- 5284: ¦WID: RP-141288->RP-142302¦Stat Rep: -->RP-141732¦Release: Rel-13->Rel-12 / Impacted TSs and TRs: 36.101; 36.104; 36.133; New 36.8xx
- 5285: ¦WID: RP-141288->RP-142302¦Stat Rep: -->RP-141732¦Release: Rel-13->Rel-12 / Impacted TSs and TRs: 36.141; 36.307
- 5286: Inter-band CA 3DL/1UL / Impacted TSs and TRs: LTE
- 5287: CD:Thu 11/12/14->Mon 15/12/14¦Compl:0%->100%¦Stat Rep: -->RP-141732¦Release: Rel-13->Rel-12 / Impacted TSs and TRs: 36.101; 36.104; 36.133; New 36.8xx
- 5288: CD:Thu 11/12/14->Mon 15/12/14¦Compl:0%->100%¦Stat Rep: -->RP-141732¦Release: Rel-13->Rel-12 / Impacted TSs and TRs: 36.141; 36.307
- 5289: Inter-band CA 3DL/1UL / Impacted TSs and TRs: LTE
- 5290: CD:Fri 11/12/15->Mon 15/12/14¦Compl:0%->100%¦Stat Rep: -->RP-141732¦Release: Rel-13->Rel-12 / Impacted TSs and TRs: 36.101; 36.104; 36.133; New 36.8xx
- 5291: CD:Thu 11/12/14->Mon 15/12/14¦Compl:0%->100%¦Stat Rep: -->RP-141732¦Release: Rel-13->Rel-12 / Impacted TSs and TRs: 36.141; 36.307
- 5292: ¦Stat Rep: RP-141444->RP-141774 1st Apr 15: Compl:75%->100% 1st Apr 15: WID: RP-140621->RP-150077 1st Apr 15: Stat Rep: RP-141774->RP-150076 / Impacted TSs and TRs: 36.508; 36.521-1; 36.521-2; 36.521-3; 36.523-1; 36.523-2; 36.523-3; 37.571-1; 37.571-3; 37.571-5
- 5293: ¦Stat Rep: -->RP-141775 1st Apr 15: Compl:6%->12% 1st Apr 15: CD:Tue 15/09/15->Tue 15/12/15 1st Apr 15: WID: RP-142231->RP-150079 1st Apr 15: Stat Rep: RP-141775->RP-150078 03/07/15: Compl:12%->35% 03/07/15: WID: RP-150079->RP-150594 03/07/15: Stat Re / Impacted TSs and TRs: 36.508; 36.521-1; 36.521-2; 36.521-3; 36.523-1; 36.523-2; 36.523-3; 37.571-1; 37.571-3; 37.571-5
- 5294: RP#60 stopped. RP#58 on hold til June 2013 / Impacted TSs and TRs: LTE
- 5295: RP#60 stopped at 40% completion. RP#58 on hold til June 2013 / Impacted TSs and TRs: 36.300; 36.413; 36.420; 36.423
- 5296: RP#58 RP-121701 work can start based on FCC Order (FCC-12-130) http://hraunfoss.fcc.gov/edocs_public/attachmatch/FCC-12-130A1.pdf / Impacted TSs and TRs: LTE
- 5297: RP#60 completed. Updated WID RP-121419=>RP-130843 / Impacted TSs and TRs: 36.101; 36.104; 36.113; 36.124; 36.133; 36.307; 36.331; new 36.846
- 5298: RP#60 completed. Updated WID RP-121419=>RP-130843 / Impacted TSs and TRs: 36.101; 36.133; 36.141
- 5299: ¦Stat Rep: RP-141166->RP-141773 / Impacted TSs and TRs: 36.508; 36.521-1; 36.521-2; 36.521-3; 36.523-2; 36.523-3; 37.571-1
- 5300: - / Impacted TSs and TRs: LTE
- 5301: RP#60 completed. TR 36.840 v100 for 1-step Approval / Impacted TSs and TRs: 36.101; 36.104; 36.113; 36.124; 36.133; 37.104; 37.113; 36.307; new 36.840
- 5302: RP#61 completed / Impacted TSs and TRs: 36.133; 36.141; 37.141
- 5303: RP#62 completed / Impacted TSs and TRs: 36.508; 36.521-1; 36.521-2; 36.521-3
- 5304: Stage 3 / Impacted TSs and TRs: LTE
- 5305: RP#64 completed / Impacted TSs and TRs: 36.211; 36.212; 36.213; 36.331
- 5306: ¦CD:Fri 12/06/15->Mon 15/06/15¦WID: RP-141966->RP-142235¦Stat Rep: RP-141378->RP-142042 / Impacted TSs and TRs: 36.101
- 5307: 03/07/15: Compl:0%->10% 03/07/15: Stat Rep: ->RP-150606 29/09/15: Compl:10%->70% 29/09/15: Stat Rep: RP-150606->RP-1511891/1/16: Compl:70%->75%

| ID | WBS | Task | Duration | Start | Finish | Complete | Remaining | Baseline start | Baseline finish | Baseline duration | Total slack | Constraint | Resources | Work | Actual work | Acronym | PCG approved | WI rapporteur name | Release | TSG approved | MCC resp | PCG stopped | TSG stopped | Acronym_3GU_Export | Status Report | Special Focus Doc |
| --- | --- | --- | --- | --- | --- | --- | --- | --- | --- | --- | --- | --- | --- | --- | --- | --- | --- | --- | --- | --- | --- | --- | --- | --- | --- | --- |
| 5308 | 1707 | **Deleted - New Carrier Type for LTE** | 265d? | 2012-09-11 A | 2013-09-06 A | 100% |  | 2012-09-11 | 2013-09-06 | 265d? |  |  | R1; R2; R4 | 14808h | 14808h | LTE_NCT | 29 | Ericsson | Rel-12 | 57 | Patrick | PCG-31 | RP-61 | LTE_NCT |  |  |
| 5309 | 1707.1 | Deleted - Core part: New Carrier Type for LTE | 265d? | 2012-09-11 A | 2013-09-06 A | 100% |  | 2012-09-11 | 2013-09-06 | 265d? |  | finish no earlier than 2013-09-06 | R1; R2; R4 | 6360h | 6360h | LTE_NCT-Core | 29 | Ericsson | Rel-12 | 57 | Patrick | PCG-31 | RP-61 | LTE_NCT-Core | RP-130984 |  |
| 5310 | 1707.2 | Deleted - Perf. part: New Carrier Type for LTE | 261d? | 2012-09-17 A | 2013-09-06 A | 100% |  | 2012-09-17 | 2013-09-06 | 261d? |  | finish no earlier than 2013-09-06 | R4 | 2088h | 2088h | LTE_NCT-Perf | 29 | Ericsson | Rel-12 | 57 | Issam | PCG-31 | RP-61 | LTE_NCT-Perf | RP-130985 |  |
| 5311 | 1708 | **Further Enhancements to LTE TDD for DL-UL Interference Management and Traffic Adaptation** | 1385d? | 2012-12-07 A | 2018-03-15 A | 100% |  | 2012-12-07 | 2014-12-05 | 527d? |  |  | R1; R2; R3; R4 | 56138.6h | 56138.6h | LTE_TDD_eIMTA | 30 | CATT | Rel-12 | 58 | Patrick |  |  | LTE_TDD_eIMTA |  | Small cell |
| 5312 | 1708.1 | Core part: Further Enhancements to LTE TDD for DL-UL Interference Management and Traffic Adaptation | 24.58d? | 2012-12-07 A | 2014-06-13 A | 100% |  | 2012-12-07 | 2014-06-13 | 24.58d? |  | finish no earlier than 2014-06-13 | R1; R2; R3; R4 | 786.56h | 786.56h | LTE_TDD_eIMTA-Core | 30 | CATT | Rel-12 | 58 | Patrick |  |  | LTE_TDD_eIMTA-Core | RP-140724 | Small cell |
| 5313 | 1708.2 | Perf. part: Further Enhancements to LTE TDD for DL-UL Interference Management and Traffic Adaptation | 725d? | 2012-12-15 A | 2015-09-15 A | 100% |  | 2012-12-07 | 2014-12-05 | 527d? |  | finish no earlier than 2015-09-15 | R4 | 5800h | 5800h | LTE_TDD_eIMTA-Perf | 30 | CATT | Rel-12 | 58 | Patrick |  |  | LTE_TDD_eIMTA-Perf | RP-151447 | Small cell |
| 5314 | 1708.3 | UE Conformance Test Aspects - Further Enhancements to LTE TDD for DL-UL Interference Management and Traffic Adaptation | 654d? | 2015-09-15 A | 2018-03-15 A | 100% |  |  |  |  |  | finish no earlier than 2018-03-15 | R5 | 5232h | 5232h | LTE_TDD_eIMTA-UEConTest | 35 | CATT | Rel-12 | 69 |  |  |  |  |  |  |
| 5315 | 1709 | **HetNet Mobility enhancements for LTE** | 641.65d? | 2012-04-13 A | 2014-09-12 A | 100% |  | 2012-04-13 | 2014-09-12 | 640.65d? |  |  | R2; R4 | 11624h | 11624h | HetNet_eMOB_LTE | 30 | Alcatel-Lucent | Rel-12 | 58 | Yong-Jun |  |  | HetNet_eMOB_LTE |  |  |
| 5316 | 1709.1 | Core part: HetNet Mobility enhancements for LTE | 263.5d? | 2012-04-13 A | 2014-09-12 A | 100% |  | 2012-04-13 | 2014-09-12 | 263.5d? |  | finish no earlier than 2014-09-12 | R2; R4 | 4216h | 4216h | HetNet_eMOB_LTE-Core | 30 | Alcatel-Lucent | Rel-12 | 58 | Yong-Jun |  |  | HetNet_eMOB_LTE-Core | RP-141413 |  |
| 5317 | 1710 | **Further enhancements for HeNB mobility-X2-GW** | 401d? | 2012-12-10 A | 2014-06-13 A | 100% |  | 2012-12-10 | 2014-06-13 | 401d? |  |  | R3 | 6408h | 6408h | EHNB_enh2_X2GW | 30 | Alcatel-Lucent | Rel-12 | 58 | Juha |  |  | EHNB_enh2_X2GW |  | HNB |
| 5318 | 1710.1 | Core part: Further enhancements for HeNB mobility-X2-GW | 400d? | 2012-12-10 A | 2014-06-13 A | 100% |  | 2012-12-10 | 2014-06-13 | 400d? |  | finish no earlier than 2014-06-13 | R3 | 3200h | 3200h | EHNB_enh2_X2GW-Core | 30 | Alcatel-Lucent | Rel-12 | 58 | Juha |  |  | EHNB_enh2_X2GW-Core | RP-140592 | HNB |
| 5319 | 1711 | **8 Rx Antennas for LTE UL** | 265d? | 2012-12-10 A | 2013-12-06 A | 100% |  | 2012-12-10 | 2013-12-06 | 265d? |  |  | R4 | 4208h | 4208h | LTE_UL_8Rx | 30 | China Telecom | Rel-12 | 58 | Issam |  |  | LTE_UL_8Rx |  |  |
| 5320 | 1711.1 | Perf. part: 8 Rx Antennas for LTE UL | 261d? | 2012-12-10 A | 2013-12-06 A | 100% |  | 2012-12-10 | 2013-12-06 | 261d? |  | finish no earlier than 2013-12-06 | R4 | 2088h | 2088h | LTE_UL_8Rx-Perf | 30 | China Telecom | Rel-12 | 58 | Issam |  |  | LTE_UL_8Rx-Perf | RP-131523 |  |
| 5321 | 1712 | **LTE TDD-FDD joint operation including Carrier Aggregation** | 444.03d? | 2013-04-12 A | 2014-12-15 A | 100% |  | 2013-04-12 | 2014-12-05 | 435.03d? |  |  | R1; R2; R4 | 14776h | 14776h | LTE_CA_TDD_FDD | 31 | Nokia | Rel-12 | 60 | Patrick |  |  | LTE_CA_TDD_FDD |  |  |
| 5322 | 1712.1 | Core part: LTE TDD-FDD joint operation including Carrier Aggregation | 87.33d? | 2013-04-12 A | 2014-06-13 A | 100% |  | 2013-04-12 | 2014-06-13 | 87.33d? |  | finish no earlier than 2014-06-13 | R1; R2; R4 | 2096h | 2096h | LTE_CA_TDD_FDD-Core | 31 | Nokia, China Mobile (for TR) | Rel-12 | 60 | Patrick |  |  | LTE_CA_TDD_FDD-Core | RP-140982 |  |
| 5323 | 1712.2 | Perf. part: LTE TDD-FDD joint operation including Carrier Aggregation | 397d? | 2013-06-15 A | 2014-12-15 A | 100% |  | 2013-06-20 | 2014-12-05 | 386d? |  | finish no earlier than 2014-12-15 | R4 | 3176h | 3176h | LTE_CA_TDD_FDD-Perf | 31 | Nokia | Rel-12 | 60 | Issam |  |  | LTE_CA_TDD_FDD-Perf | RP-141972 |  |
| 5324 | 1713 | **LTE Coverage Enhancements** | 604.17d? | 2013-03-01 A | 2015-06-15 A | 100% |  | 2013-03-01 | 2014-12-05 | 465.17d? |  |  | R1; R2; R4; R5 | 21348.1h | 21348.1h | Cov_Enh_LTE | 31 | China Telecom | Rel-12 | 60 | Patrick |  |  | Cov_Enh_LTE |  |  |
| 5325 | 1713.1 | Core part: LTE Coverage Enhancements | 87d? | 2013-03-01 A | 2014-06-13 A | 100% |  | 2013-03-01 | 2014-06-13 | 87d? |  | finish no earlier than 2014-06-13 | R1; R2; R4 | 2088h | 2088h | Cov_Enh_LTE-Core | 31 | China Telecom | Rel-12 | 60 | Patrick |  |  | Cov_Enh_LTE-Core | RP-140683 |  |
| 5326 | 1713.2 | Perf. part: LTE Coverage Enhancements | 397d? | 2013-06-15 A | 2014-12-15 A | 100% |  | 2013-06-20 | 2014-12-05 | 386d? |  | finish no earlier than 2014-12-15 | R4 | 3176h | 3176h | Cov_Enh_LTE-Perf | 31 | China Telecom | Rel-12 | 60 | Issam |  |  | Cov_Enh_LTE-Perf | RP-141833 |  |
| 5327 | 1713.3 | Test part: LTE Coverage Enhancements | 198d? | 2014-09-15 A | 2015-06-15 A | 100% |  |  |  |  |  | finish no earlier than 2015-09-15 | R5 | 1584h | 1584h | Cov_Enh_LTE-UEConTest | 33 | China Telecom | Rel-12 | 65 |  |  |  | Cov_Enh_LTE-UEConTest | RP-150631 |  |
| 5328 | 1714 | **Further MBMS operations support for E-UTRAN** | 330d? | 2013-09-15 A | 2014-12-15 A | 100% |  | 2013-12-09 | 2014-09-12 | 201d? |  |  | R2; R1; R3; R4 | 21280h | 21280h | MBMS_LTE_OS | 31 | Verizon | Rel-12 | 61 | Yong-Jun |  |  | MBMS_LTE_OS |  |  |
| 5329 | 1714.1 | Core part: Further MBMS operations support for E-UTRAN | 329d? | 2013-09-15 A | 2014-12-15 A | 100% |  | 2014-04-04 | 2014-09-12 | 115.25d? |  | finish no earlier than 2014-12-15 | R2; R1; R3; R4 | 10528h | 10528h | MBMS_LTE_OS-Core | 31 | Verizon | Rel-12 | 61 | Yong-Jun |  |  | MBMS_LTE_OS-Core | RP-141821 |  |
| 5330 | 1714.2 | Perf. part: Further MBMS operations support for E-UTRAN | 264d? | 2013-12-15 A | 2014-12-15 A | 100% |  | 2013-12-09 | 2014-09-12 | 201d? |  | finish no earlier than 2014-12-15 | R4 | 2112h | 2112h | MBMS_LTE_OS-Perf | 32 | Verizon | Rel-12 | 62 | Issam |  |  | MBMS_LTE_OS-Perf | RP-141821 |  |
| 5331 | 1715 | **Dual connectivity for LTE** | 985d? | 2013-12-15 A | 2017-09-15 | 99% | 0d? | 2013-12-09 | 2014-12-05 | 261d? | 0d |  | R2; R1; R3; R4; S2; C4 | 49408h | 49408h | LTE_SC_enh_dualC | 32 | NTT DOCOMO | Rel-12 | 62 | Yong-Jun |  |  | LTE_SC_enh_dualC |  | Small cell |
| 5332 | 1715.1 | Core part: Dual connectivity for LTE | 264d? | 2013-12-15 A | 2014-12-15 A | 100% |  | 2014-04-29 | 2014-09-12 | 99d? |  | finish no earlier than 2014-12-15 | R2; R1; R3; R4 | 8448h | 8448h | LTE_SC_enh_dualC-Core | 32 | NTT DOCOMO, NEC | Rel-12 | 62 | Yong-Jun |  |  | LTE_SC_enh_dualC-Core | RP-141796 | Small cell |
| 5333 | 1715.2 | Perf. part: Dual Connectivity for LTE | 395d? | 2013-12-15 A | 2015-06-15 A | 100% |  | 2013-12-09 | 2014-12-05 | 261d? |  | finish no earlier than 2015-06-15 | R4 | 3160h | 3160h | LTE_SC_enh_dualC-Perf | 32 | NTT DOCOMO | Rel-12 | 62 | Issam |  |  | LTE_SC_enh_dualC-Perf | RP-150791 | Small cell |
| 5334 | 1715.3 | SA2 part of Dual connectivity for LTE | 131d? | 2014-03-19 A | 2014-09-17 A | 100% |  | 2014-03-19 | 2014-09-17 | 131d? |  | finish no earlier than 2014-09-17 | S2 | 1048h | 1048h | LTE_SC_enh_dualC-S2 | 32 |  | Rel-12 | 63 |  |  |  |  |  | Small cell |
| 5335 | 1715.4 | CT aspects of Dual connectivity for LTE | 63d? | 2014-09-12 A | 2014-12-09 A | 100% |  |  |  |  |  | finish no earlier than 2014-12-09 | C4 | 504h | 504h | LTE_SC_enh_dualC-CT | 33 | Huawei | Rel-12 | 65 |  |  |  | LTE_SC_enh_dualC-CT | CP-140487 | Small cell |
| 5336 | 1715.5 | UE Conformance Test Aspects - Dual connectivity for LTE | 591d? | 2015-06-15 A | 2017-09-15 A | 100% |  |  |  |  |  | finish no earlier than 2017-09-15 | R5 | 4728h | 4728h | LTE_SC_enh_dualC-UEConTest | 35 | Ericsson | Rel-12 | 68 |  |  |  |  |  |  |

Notes:
- 5308: RP#61 stopped. Continue discussion on use cases and requirements for a NCT in LTE beyond Rel-12. Action: Ericsson to provide at RP#62 a summary of work done so far / Impacted TSs and TRs: LTE / WI rapporteur e-mail: daniel.n.larsson@ericsson.com
- 5309: RP#61 stopped at 20% completion / Impacted TSs and TRs: 36.101; 36.104; 36.133; 36.211; 36.212; 36.213; 36.321; 36.331 / WI rapporteur e-mail: daniel.n.larsson@ericsson.com
- 5310: RP#61 stopped at 0% completion / Impacted TSs and TRs: 36.101; 36.104; 36.133; 36.141 / WI rapporteur e-mail: daniel.n.larsson@ericsson.com
- 5311: Stage 3. Triggered by Rel-11 TR 36.828 Study on Further Enhancements to LTE TDD for DL-UL Interference Management and Traffic Adaptation (FS_LTE_TDD_eIMTA) UID_510039 / Impacted TSs and TRs: LTE / WI rapporteur e-mail: Zukang Shen (shenzukang@catt.cn)
- 5312: RP#64 completed / Impacted TSs and TRs: 36.101; 36.104; 36.133; 36.211; 36.212; 36.213; 36.214; 36.300; 36.321; 36.331; 36.413; 36.423 / WI rapporteur e-mail: Zukang Shen (shenzukang@catt.cn)
- 5313: ¦CD:Thu 18/06/15->Mon 15/06/15¦WID: RP-141966->RP-142235¦Stat Rep: RP-141342->RP-141948 1st Apr 15: Compl:30%->55% 1st Apr 15: Stat Rep: RP-141948->RP-150154 03/07/15: Compl:55%->95% 03/07/15: CD:Mon 15/06/15->Tue 15/09/15 03/07/15: Stat Rep: RP-150 / Impacted TSs and TRs: 36.101; 36.104; 36.133; 36.141 / WI rapporteur e-mail: Zukang Shen (shenzukang@catt.cn)
- 5314: tested: REL-12 WI LTE_TDD_eIMTA-Core;1/1/16: Compl:0%->5%¦22/3/16: Compl:5%->15% 21/3/ 19 827/3
- 5315: Stage 3. Triggered by Rel-11 TR 36.839 Study on HetNet mobility enhancements for LTE (FS_HetNet_eMOB_LTE) / Impacted TSs and TRs: LTE / WI rapporteur e-mail: sudeep.palat@alcatel-lucent.com
- 5316: SP#65 completed / Impacted TSs and TRs: 36.133; 36.304; 36.331 / WI rapporteur e-mail: sudeep.palat@alcatel-lucent.com
- 5317: Rel-10 H(e)NB Mobility Enhancements adds signalling via horizontal RAN interfaces (Iurh, X2) to support H(e)NB to H(e)NB mobility. Rel-11 TR37.803 triggered WI UID_560014 partly completed in Rel-11¦remaining work including solution definition is Rel-12 / Impacted TSs and TRs: LTE / WI rapporteur e-mail: Philippe.Godin@alcatel-lucent.com
- 5318: RP#64 completed / Impacted TSs and TRs: 36.300; 36.413; 36.423 / WI rapporteur e-mail: Philippe.Godin@alcatel-lucent.com
- 5319: WI has perf. part only (as change from 4Rx to 8Rx has no Core spec impact) / Impacted TSs and TRs: LTE / WI rapporteur e-mail: Shan Yang (yangshan@ctbri.com.cn)
- 5320: RP#62 completed / Impacted TSs and TRs: 36.104; 36.141 / WI rapporteur e-mail: Shan Yang (yangshan@ctbri.com.cn)
- 5321: - / Impacted TSs and TRs: LTE / WI rapporteur e-mail: lars.e.lindh@nokia.com
- 5322: RP#64 completed / Impacted TSs and TRs: 36.101; 36.104; 36.133; 36.201; 36.211; 36.212; 36.213; 36.300; 36.302; 36.306; 36.331; new 36.847 / WI rapporteur e-mail: lars.e.lindh@nokia.com, Xiaodong Shen (shenxiaodong@chinamobile.com)
- 5323: ¦CD:Thu 18/06/15->Mon 15/06/15¦WID: RP-130848->RP-140522¦Stat Rep: RP-141374->RP-141972 / Impacted TSs and TRs: 36.101; 36.104; 36.133 / WI rapporteur e-mail: lars.e.lindh@nokia.com
- 5324: Triggered by Rel-11 TR 36.824 (FS_Cov_Enh_LTE) / Impacted TSs and TRs: LTE / WI rapporteur e-mail: Xiaoming She (shexm@ctbri.com.cn)
- 5325: RP#64 completed / Impacted TSs and TRs: 36.101; 36.104; 36.133; 36.211; 36.212; 36.213; 36.300; 36.321; 36.331 / WI rapporteur e-mail: Xiaoming She (shexm@ctbri.com.cn)
- 5326: ¦CD:Thu 18/06/15->Mon 15/06/15¦WID: RP-141966->RP-142235¦Stat Rep: RP-141149->RP-141833 / Impacted TSs and TRs: 36.101; 36.104; 36.133; 36.141 / WI rapporteur e-mail: Xiaoming She (shexm@ctbri.com.cn)
- 5327: ¦Stat Rep: -->RP-141834 03/07/15: Compl:5%->100% 03/07/15: CD:Tue 15/09/15->Mon 15/06/15 03/07/15: Stat Rep: RP-141834->RP-150631 / Impacted TSs and TRs: 36.508; 36.523-1; 36.523-2; 36.523-3 / WI rapporteur e-mail: YANG Shan (yangshan@ctbri.com.cn)
- 5328: Solutions for Minimization of Drive Tests (MDT), in order to reduce the need for manual drive testing for MBMS. / Impacted TSs and TRs: LTE / WI rapporteur e-mail: yeesin.chan@verizonwireless.com
- 5329: ¦CD:Thu 18/06/15->Mon 15/06/15¦WID: RP-130848->RP-140522¦Stat Rep: RP-141431->RP-141821 / Impacted TSs and TRs: 36.133; 36.214; 36.300; 36.304; 36.306; 36.331; 36.413; 36.423; 37.320 / WI rapporteur e-mail: yeesin.chan@verizonwireless.com
- 5330: ¦CD:Wed 17/12/14->Mon 15/12/14¦WID: RP-130848->RP-140522¦Stat Rep: RP-141431->RP-141821 / Impacted TSs and TRs: 36.133 / WI rapporteur e-mail: yeesin.chan@verizonwireless.com
- 5331: Triggered by TR 36.842 Study on Small Cell Enhancements for E-UTRA and E-UTRAN Higher-layer aspects (UID_580044) / Impacted TSs and TRs: LTE / WI rapporteur e-mail: tooru.uchino.fv@nttdocomo.com
- 5332: ¦CD:Wed 18/03/15->Sun 15/03/15¦WID: RP-130848->RP-140522¦Stat Rep: RP-141264->RP-141796 / Impacted TSs and TRs: 36.101; 36.104; 36.133; 36.211; 36.212; 36.213; 36.300; 36.302; 36.306; 36.321; 36.322; 36.323; 36.331; 36.410; 36.413; 36.420; 36.423; new RAN3 36.425 / WI rapporteur e-mail: RAN1/2/4 tooru.uchino.fv@nttdocomo.com, RAN3 Chenghock Ng (ngcheng@da.jp.nec.com)
- 5333: ¦Stat Rep: RP-141264->RP-141796 1st Apr 15: Compl:15%->45% 1st Apr 15: Stat Rep: RP-141796->RP-150160 03/07/15: Compl:45%->100% 03/07/15: Stat Rep: RP-150160->RP-150791 / Impacted TSs and TRs: 36.101; 36.104; 36.133 / WI rapporteur e-mail: kunihiko.teshima.hg@nttdocomo.com
- 5334: SP#64 Three CRs agreed in SP-140262 (23.251CR0099, 23.401CR2658&CR2707). Dec.14:99->100% / Impacted TSs and TRs: 23.251; 23.401
- 5335: Stage 2/3. CP#65 exception in CP-140487. LM70->100 / Impacted TSs and TRs: 23.007; 23.008; 29.274; 29.281 / WI rapporteur e-mail: Xiaoyan SHI (sean.shixiaoyan@huawei.com)
- 5336: tested Core part: LTE_SC_enh_dualC-Core 29/09/15: Compl:0%->3% 29/09/15: Stat Rep: -->RP-1511671/1/16: Compl:3%->15%1/1/16: CD:Tue 15/03/16->Wed 15/06/16¦ ;

| ID | WBS | Task | Duration | Start | Finish | Complete | Baseline start | Baseline finish | Baseline duration | Constraint | Resources | Work | Actual work | Acronym | PCG approved | WI rapporteur name | WI rapporteur e-mail | Release | TSG approved | MCC resp | Special Focus Doc | Acronym_3GU_Export | Status Report |
| --- | --- | --- | --- | --- | --- | --- | --- | --- | --- | --- | --- | --- | --- | --- | --- | --- | --- | --- | --- | --- | --- | --- | --- |
| 5337 | 1716 | **E-UTRA Small cell enhancements - Physical layer aspects** | 919d? | 2013-12-15 A | 2017-06-15 A | 100% | 2013-07-19 | 2014-12-05 | 364.75d? |  | R1; R2; R4 | 32364.7h | 32364.7h | LTE_SC_enh_L1 | 32 | Huawei | Elean FAN (fanxiaoan@huawei.com) | Rel-12 | 62 | Patrick | Small cell | LTE_SC_enh_L1 |  |
| 5338 | 1716.1 | Core part: E-UTRA Small cell enhancements - Physical layer aspects | 161.25d? | 2013-12-15 A | 2014-12-15 A | 100% | 2013-07-19 | 2014-09-12 | 202d? | finish no earlier than 2014-12-15 | R1; R2; R4 | 3870h | 3870h | LTE_SC_enh_L1-Core | 32 | Huawei | Elean FAN (fanxiaoan@huawei.com) | Rel-12 | 62 | Patrick | Small cell | LTE_SC_enh_L1-Core | RP-141899 |
| 5339 | 1716.2 | Perf. part: E-UTRA Small cell enhancements - Physical layer aspects | 394d? | 2013-12-15 A | 2015-06-15 A | 100% | 2013-12-09 | 2014-12-05 | 261d? | finish no earlier than 2015-06-15 | R4 | 3152h | 3152h | LTE_SC_enh_L1-Perf | 32 | Huawei | Elean FAN (fanxiaoan@huawei.com) | Rel-12 | 62 | Issam | Small cell | LTE_SC_enh_L1-Perf | RP-150690 |
| 5340 | 1716.3 | UE Conformance Test Aspects - E-UTRA Small cell enhancements - Physical layer aspects | 525d? | 2015-06-15 A | 2017-06-15 A | 100% |  |  |  | finish no earlier than 2017-06-15 | R5 | 4200h | 4200h | LTE_SC_enh_L1-UEConTest | 35 | Huawei |  | Rel-12 | 68 |  |  |  |  |
| 5341 | 1717 | **Inter-eNB Coordinated Multi-Point (CoMP) for LTE** | 264d? | 2013-12-15 A | 2014-12-12 A | 100% | 2014-03-14 | 2014-09-12 | 130.65d? |  | R3; R1 | 4738.38h | 4738.38h | COMP_LTE_IeNB | 32 | Samsung | Sung Hwan Won (sunghwan.won@samsung.com) | Rel-12 | 62 | Juha |  | COMP_LTE_IeNB |  |
| 5342 | 1717.1 | Core part: Inter-eNB Coordinated Multi-Point (CoMP) for LTE | 165.5d? | 2013-12-15 A | 2014-12-12 A | 100% | 2014-03-14 | 2014-09-12 | 100.5d? | finish no earlier than 2014-12-15 | R3; R1 | 2648h | 2648h | COMP_LTE_IeNB-Core | 32 | Samsung | Sung Hwan Won (sunghwan.won@samsung.com) | Rel-12 | 62 | Juha |  | COMP_LTE_IeNB-Core | RP-141804 |
| 5343 | 1718 | **Smart Congestion Mitigation in E-UTRAN** | 403d? | 2014-03-05 A | 2015-09-15 A | 100% | 2014-03-05 | 2014-09-12 | 138d? |  | R2; S1; C1 | 12376h | 12376h | SCM_LTE | 32 | LG Electronics | youngdae.lee@lge.com | Rel-12 | 63 | Yong-Jun |  | SCM_LTE |  |
| 5344 | 1718.1 | Core part: Smart Congestion Mitigation in E-UTRAN | 137d? | 2014-03-06 A | 2014-09-12 A | 100% | 2014-03-06 | 2014-09-12 | 137d? | finish no earlier than 2014-09-12 | R2 | 1096h | 1096h | SCM_LTE-Core | 32 | LG Electronics | youngdae.lee@lge.com | Rel-12 | 63 | Yong-Jun |  | SCM_LTE-Core | RP-141292 |
| 5345 | 1718.2 | Stage 1 Prioritization of Multimedia Telephony (MMTel) and Mobile Originating-SMS for Access Class Barring (ACB) | 3d? | 2014-03-05 A | 2014-03-07 A | 100% | 2014-03-05 | 2014-03-07 | 3d? | finish no earlier than 2013-12-11 | S1 | 24h | 24h |  | 33 |  |  | Rel-12 | 64 |  |  |  |  |
| 5346 | 1718.3 | CT aspects of Smart Congestion Mitigation in E-UTRAN (Stage 3) | 66d? | 2014-06-13 A | 2014-09-11 A | 100% | 2014-06-13 | 2014-09-12 | 66d? | start no earlier than 2014-06-13 | C1 | 528h | 528h | SCM_LTE-CT | 33 | LG Electronics | Kim, Jaehyun (jaehyun7.kim@lge.com) | Rel-12 | 64 |  |  | SCM_LTE-CT |  |
| 5347 | 1718.4 | UE Conformance Test Aspects - Smart Congestion Mitigation in E-UTRAN | 132d? | 2015-03-16 A | 2015-09-15 A | 100% |  |  |  | finish no earlier than 2015-09-15 | R5 | 1056h | 1056h | SCM_LTE-UEConTest | 34 | NTT DOCOMO |  | Rel-12 | 67 |  |  |  | RP-151445 |
| 5348 | 1719 | **Positioning Enhancements for RF Pattern Matching in E-UTRA** | 36d? | 2014-04-25 A | 2014-06-13 A | 100% | 2014-04-25 | 2014-06-13 | 36d? |  | R3; R2 | 1152h | 1152h | LCS_LTE_RFPMT | 32 | Polaris Wireless | Gordon Scot (sgordon@polariswireless.com) | Rel-12 | 63 | Juha |  | LCS_LTE_RFPMT |  |
| 5349 | 1719.1 | Core part: Positioning Enhancements for RF Pattern Matching in E-UTRA | 36d? | 2014-04-25 A | 2014-06-13 A | 100% | 2014-04-25 | 2014-06-13 | 36d? | finish no earlier than 2014-06-13 | R3; R2 | 576h | 576h | LCS_LTE_RFPMT-Core | 32 | Polaris Wireless | Gordon Scot (sgordon@polariswireless.com) | Rel-12 | 63 | Juha |  | LCS_LTE_RFPMT-Core | RP-140591 |
| 5350 | 1720 | **Network-Assisted Interference Cancellation and Suppression for LTE** | 791d? | 2014-03-11 A | 2017-03-15 A | 100% | 2014-03-06 | 2015-06-12 | 332d? |  | R1; R2; R4; R3 | 15467.9h | 15467.9h | LTE_NAICS | 32 | MediaTek | Craig.Burnet@mediatek.com | Rel-12 | 63 | Patrick |  | LTE_NAICS |  |
| 5351 | 1720.1 | Core part: Network-Assisted Interference Cancellation and Suppression for LTE | 113.67d? | 2014-07-11 A | 2014-12-15 A | 100% | 2014-07-11 | 2014-09-12 | 45.67d? | finish no earlier than 2014-12-15 | R1; R2; R4; R3 | 2803.87h | 2803.87h | LTE_NAICS-Core | 32 | MediaTek | Craig.Burnet@mediatek.com | Rel-12 | 63 | Patrick |  | LTE_NAICS-Core | RP-141866 |
| 5352 | 1720.2 | Perf. part: Network-Assisted Interference Cancellation and Suppression for LTE | 399d? | 2014-03-11 A | 2015-09-15 A | 100% | 2014-03-06 | 2015-06-12 | 332d? | finish no earlier than 2015-09-15 | R4 | 3192h | 3192h | LTE_NAICS-Perf | 32 | MediaTek | Craig.Burnet@mediatek.com | Rel-12 | 63 | Issam |  | LTE_NAICS-Perf | RP-151296 |
| 5353 | 1720.3 | UE Conformance Test Aspects: Network-Assisted Interference Cancellation and Suppression for LTE | 393d? | 2015-09-15 A | 2017-03-15 A | 100% |  |  |  | finish no earlier than 2017-03-15 | R5 | 3144h | 3144h | LTE_NAICS-UEConTest | 35 | Mediatek |  | Rel-12 | 69 |  |  |  |  |
| 5354 | 1721 | **Performance requirements of interference cancellation and suppression receiver for SU-MIMO** | 467d? | 2014-03-06 A | 2015-12-15 A | 100% | 2014-03-06 | 2015-03-13 | 267d? |  | R4 | 7448h | 7448h | LTE_SUMIMO_RX | 32 | Huawei | Qian Cheng (Q.Cheng@Huawei.com) | Rel-12 | 63 | Issam |  | LTE_SUMIMO_RX |  |
| 5355 | 1721.1 | Perf. part: Performance requirements of interference cancellation and suppression receiver for SU-MIMO | 267d? | 2014-03-06 A | 2015-03-13 A | 100% | 2014-03-06 | 2015-03-13 | 267d? | finish no earlier than 2015-03-15 | R4 | 2136h | 2136h | LTE_SUMIMO_RX-Perf | 32 | Huawei | Qian Cheng (Q.Cheng@Huawei.com) | Rel-12 | 63 | Issam |  | LTE_SUMIMO_RX-Perf | RP-150229 |
| 5356 | 1721.2 | UE Conformance Test Aspects - Performance Requirements of Interference Cancellation and Suppression Receiver for SU-MIMO for E-UTRA | 197d? | 2015-03-16 A | 2015-12-15 A | 100% |  |  |  | finish no earlier than 2016-03-15 | R5 | 1576h | 1576h | LTE_SUMIMO_RX-UEConTest | 34 | Huawei |  | Rel-12 | 67 |  |  |  | RP-151245 |
| 5357 | 1722 | **HSPA signalling enhancements for more efficient resource usage for LCR** | 274d? | 2012-12-11 A | 2013-12-20 A | 100% | 2012-12-10 | 2013-12-06 | 265d? |  | R1; R2; R3; R4 | 16832h | 16832h | LCR_TDD_HSPA_sign_enh | 30 | CATT | Yanping Xing (xingyanping@catt.cn) | Rel-12 | 58 | Patrick |  | LCR_TDD_HSPA_sign_enh |  |
| 5358 | 1722.1 | Core part: HSPA signalling enhancements for more efficient resource usage for LCR TDD | 270d? | 2012-12-15 A | 2013-12-20 A | 100% | 2012-12-10 | 2013-12-06 | 265d? | finish no earlier than 2013-12-15 | R1; R2; R3 | 6480h | 6480h | LCR_TDD_HSPA_sign_enh-Core | 30 | CATT | Yanping Xing (xingyanping@catt.cn) | Rel-12 | 58 | Patrick |  | LCR_TDD_HSPA_sign_enh-Core | RP-131499 |
| 5359 | 1722.2 | Perf. part: HSPA signalling enhancements for more efficient resource usage for LCR TDD | 198d? | 2012-12-11 A | 2013-09-06 A | 100% | 2012-12-11 | 2013-09-06 | 198d? | finish no earlier than 2013-09-06 | R4 | 1584h | 1584h | LCR_TDD_HSPA_sign_enh-Perf | 30 | CATT | Yanping Xing (xingyanping@catt.cn) | Rel-12 | 58 | Issam |  | LCR_TDD_HSPA_sign_enh-Perf | RP-130968 |
| 5360 | 1723 | **HNB Positioning for UTRA** | 127d? | 2013-06-18 A | 2013-12-06 A | 100% | 2013-06-18 | 2013-12-06 | 127d? |  | R3 | 2032h | 2032h | UTRA_HNB_Pos | 31 | Alcatel-Lucent | Martin.Warner@alcatel-lucent.com | Rel-12 | 60 | Juha | HNB | UTRA_HNB_Pos |  |
| 5361 | 1723.1 | Core part: HNB Positioning for UTRA | 127d? | 2013-06-18 A | 2013-12-06 A | 100% | 2013-06-18 | 2013-12-06 | 127d? | finish no earlier than 2013-12-06 | R3 | 1016h | 1016h | UTRA_HNB_Pos-Core | 31 | Alcatel-Lucent | Martin.Warner@alcatel-lucent.com | Rel-12 | 60 | Juha | HNB | UTRA_HNB_Pos-Core | RP-131974 |

Notes:
- 5337: Triggered by TR 36.872 Study on Small Cell Enhancements for E-UTRA and E-UTRAN Physical-layer aspects (UID_580041) / Impacted TSs and TRs: LTE
- 5338: ¦CD:Tue 12/05/15->Mon 15/12/14¦WID: RP-130848->RP-140522¦Stat Rep: RP-141632->RP-141899 / Impacted TSs and TRs: 36.101; 36.104; 36.133; 36.211; 36.212; 36.213; 36.214; 36.300; 36.306; 36.321; 36.331; 36.413; 36.423; 36.443
- 5339: ¦CD:Wed 18/03/15->Sun 15/03/15¦WID: RP-130848->RP-140522¦Stat Rep: RP-141632->RP-141899 1st Apr 15: Compl:40%->80% 1st Apr 15: CD:Sun 15/03/15->Mon 15/06/15 1st Apr 15: Stat Rep: RP-141899->RP-150173 03/07/15: Compl:80%->100% 03/07/15: Stat Rep: RP- / Impacted TSs and TRs: 36.101; 36.104; 36.133; 36.141
- 5340: tested Core part: LTE_SC_enh_L1-Core 29/09/15: Compl:0%->10% 29/09/15: CD:Wed 15/06/16->Thu 15/12/16 29/09/15: Stat Rep: -->RP-151247¦1/1/16: Compl:10%->40%¦
- 5341: Stage 3. Rel-11 did not address support of a network interface for CoMP involving multiple eNBs with non-ideal backhaul (affected operators might not take advantage of performance benefit from inter-eNB CoMP operation). / Impacted TSs and TRs: LTE
- 5342: CD:Thu 11/12/14->Mon 15/12/14¦Compl:85%->100%¦Stat Rep: RP-140597->RP-141804 / Impacted TSs and TRs: 36.300; 36.423
- 5343: follow-up of TR 36.848 FS_SCM_LTE / Impacted TSs and TRs: LTE
- 5344: RP#65 completed / Impacted TSs and TRs: 36.331
- 5345: SP#63 SP-140065 CR under TEI12 / Impacted TSs and TRs: 22.011
- 5346: CP#65 completed / Impacted TSs and TRs: 24.173; 24.301; 24.341; 27.007
- 5347: 03/07/15: Compl:0%->60% 03/07/15: WID: RP-150202->RP-150797 03/07/15: Stat Rep: ->RP-150794 29/09/15: Compl:60%->100% 29/09/15: Stat Rep: RP-150794->RP-151445
- 5348: follow-up of TR 36.809 FS_LCS_LTE_RFPMT / Impacted TSs and TRs: LTE
- 5349: RP#64 completed / Impacted TSs and TRs: 36.305; 36.455
- 5350: follow-up of TR 36.866 FS_LTE_NAICS / Impacted TSs and TRs: LTE
- 5351: CD:Mon 08/12/14->Mon 15/12/14¦Compl:95%->100%¦Stat Rep: RP-141621->RP-141866 / Impacted TSs and TRs: 36.211; 36.213; 36.300; 36.331; 36.423
- 5352: CD:Fri 12/06/15->Mon 15/06/15¦Compl:0%->25%¦Stat Rep: RP-141621->RP-141866 1st Apr 15: Compl:25%->50% 1st Apr 15: Stat Rep: RP-141866->RP-150179 03/07/15: Compl:50%->85% 03/07/15: CD:Mon 15/06/15->Tue 15/09/15 03/07/15: Stat Rep: RP-150179->RP-150862 / Impacted TSs and TRs: 36.101
- 5353: tested: LTE_NAICS was a REL-12 RAN1 WI¦1/1/16: Compl:0%->35%¦1/1/16: WID: RP-151298->RP-151945¦
- 5354: no Core part / Impacted TSs and TRs: LTE
- 5355: CD:Fri 13/03/15->Sun 15/03/15¦Compl:50%->80%¦Stat Rep: RP-141255->RP-141906 1st Apr 15: Compl:80%->100% 1st Apr 15: Stat Rep: RP-141906->RP-150229 / Impacted TSs and TRs: 36.101
- 5356: 03/07/15: Compl:0%->5% 03/07/15: Stat Rep: ->RP-150692 29/09/15: Compl:5%->55% 29/09/15: WID: RP-150245->RP-151463 29/09/15: Stat Rep: RP-150692->RP-1512451/1/16: Compl:55%->100%1/1/16: CD:Tue 15/03/16->Tue 15/1
- 5357: Stage 2/3. Triggered by Rel-11 TR 25.874 Study on HSPA feedback and signalling efficiency enhancements for LCR TDD (FS_LCRTDD_HSPAenh) UID_540026 / Impacted TSs and TRs: UTRA
- 5358: Prev CD:Fri 06/12/13¦Prev %:100% / Impacted TSs and TRs: 25.222; 25.224; 25.331; 25.423; 25.433
- 5359: RP#61 completed / Impacted TSs and TRs: 25.102
- 5360: RP#62 completed / Impacted TSs and TRs: UTRA
- 5361: RP#62 closed at 85% completion. Not completed work on HNB positioning / No consensus (may be TEI12, if contribution and support). Updated WID RP-130868=>RP-132037 (HNB positiong was not addressed in this WI, however it was NOT remoded from the WID) / Impacted TSs and TRs: 25.305; 25.467; new 25.470

| ID | WBS | Task | Duration | Start | Finish | Complete | Remaining | Baseline start | Baseline finish | Baseline duration | Total slack | Constraint | Resources | Work | Actual work | Acronym | PCG approved | WI rapporteur name | WI rapporteur e-mail | Release | TSG approved | MCC resp | Acronym_3GU_Export | Status Report | Special Focus Doc | PCG stopped | TSG stopped |
| --- | --- | --- | --- | --- | --- | --- | --- | --- | --- | --- | --- | --- | --- | --- | --- | --- | --- | --- | --- | --- | --- | --- | --- | --- | --- | --- | --- |
| 5362 | 1724 | **Dedicated Channel (DCH) enhancements for UMTS** | 722d? | 2013-09-15 A | 2016-06-15 A | 100% |  | 2013-09-10 | 2014-12-05 | 326d? |  |  | R1; R2; R3; R4 | 32048h | 32048h | UTRA_DCHenh | 31 | Qualcomm | arjunb@qti.qualcomm.com | Rel-12 | 61 | Patrick | UTRA_DCHenh |  |  |  |  |
| 5363 | 1724.1 | Core part: Dedicated Channel (DCH) enhancements for UMTS | 115.25d? | 2013-11-18 A | 2014-09-12 A | 100% |  | 2013-11-18 | 2014-09-12 | 115.25d? |  | finish no earlier than 2014-09-12 | R1; R2; R3; R4 | 3688h | 3688h | UTRA_DCHenh-Core | 31 | Qualcomm | arjunb@qti.qualcomm.com | Rel-12 | 61 | Patrick | UTRA_DCHenh-Core | RP-141137 |  |  |  |
| 5364 | 1724.2 | Perf. part: Dedicated Channel (DCH) enhancements for UMTS | 329d? | 2013-09-15 A | 2014-12-15 A | 100% |  | 2013-09-10 | 2014-12-05 | 326d? |  | finish no earlier than 2014-12-15 | R4 | 2632h | 2632h | UTRA_DCHenh-Perf | 31 | Qualcomm | arjunb@qti.qualcomm.com | Rel-12 | 61 | Issam | UTRA_DCHenh-Perf | RP-141970 |  |  |  |
| 5365 | 1724.3 | UE Conformance Test Aspects - DCH Enhancements for UMTS | 328d? | 2015-03-16 A | 2016-06-15 A | 100% |  |  |  |  |  | finish no earlier than 2016-06-15 | R5 | 2624h | 2624h | UTRA_DCHenh-UEConTest | 34 | Qualcomm | NA | Rel-12 | 67 |  |  | RP-151279 |  |  |  |
| 5366 | 1725 | **UMTS Mobility enhancements for heterogeneous networks** | 237.85d? | 2013-07-23 A | 2014-06-13 A | 100% |  | 2013-07-23 | 2014-06-13 | 237.85d? |  |  | R2; R3; R4 | 8040h | 8040h | UTRA_HetNet_mob | 31 | Huawei | Xudong Yang (yangxudong@huawei.com) | Rel-12 | 61 | Yong-Jun | UTRA_HetNet_mob |  |  |  |  |
| 5367 | 1725.1 | Core part: UMTS Mobility enhancements for heterogeneous networks | 67d? | 2013-07-23 A | 2014-06-13 A | 100% |  | 2013-07-23 | 2014-06-13 | 67d? |  | finish no earlier than 2014-06-13 | R2; R3; R4 | 1608h | 1608h | UTRA_HetNet_mob-Core | 31 | Huawei | Xudong Yang (yangxudong@huawei.com) | Rel-12 | 61 | Yong-Jun | UTRA_HetNet_mob-Core | RP-140636 |  |  |  |
| 5368 | 1725.2 | Perf. part: UMTS Mobility enhancements for heterogeneous networks | 201d? | 2013-09-09 A | 2014-06-13 A | 100% |  | 2013-09-09 | 2014-06-13 | 201d? |  | finish no earlier than 2014-06-13 | R4 | 1608h | 1608h | UTRA_HetNet_mob-Perf | 31 | Huawei | Xudong Yang (yangxudong@huawei.com) | Rel-12 | 61 | Issam | UTRA_HetNet_mob-Perf | RP-140636 |  |  |  |
| 5369 | 1726 | **UMTS Heterogeneous Networks enhancements** | 271d? | 2013-12-06 A | 2014-12-15 A | 100% |  | 2013-12-06 | 2014-12-05 | 262d? |  |  | R1; R2; R3; R4 | 12408h | 12408h | UTRA_HetNet_enh | 32 | Huawei | carmela.cozzo@huawei.com | Rel-12 | 62 | Patrick | UTRA_HetNet_enh |  |  |  |  |
| 5370 | 1726.1 | Core part: Heterogeneous Networks enhancements | 202d? | 2013-12-06 A | 2014-09-12 A | 100% |  | 2013-12-06 | 2014-09-12 | 202d? |  | finish no earlier than 2014-09-15 | R1 | 1616h | 1616h | UTRA_HetNet_enh-Core | 32 | Huawei | carmela.cozzo@huawei.com | Rel-12 | 62 | Patrick | UTRA_HetNet_enh-Core | RP-141702 |  |  |  |
| 5371 | 1726.2 | Perf. part: Heterogeneous Networks enhancements | 265d? | 2013-12-15 A | 2014-12-15 A | 100% |  | 2013-12-09 | 2014-12-05 | 261d? |  | finish no earlier than 2014-12-15 | R4 | 2120h | 2120h | UTRA_HetNet_enh-Perf | 32 | Huawei | carmela.cozzo@huawei.com | Rel-12 | 62 | Issam | UTRA_HetNet_enh-Perf | RP-141898 |  |  |  |
| 5372 | 1727 | **Enhanced Broadcast of System Information** | 271d? | 2013-12-06 A | 2014-12-15 A | 100% |  | 2013-12-06 | 2014-12-05 | 262d? |  |  | R2; R1; R3; R4 | 16385.6h | 16385.6h | UTRA_SIBenh | 32 | Ericsson | martin.van.der.zee@ericsson.com | Rel-12 | 62 | Yong-Jun | UTRA_SIBenh |  |  |  |  |
| 5373 | 1727.1 | Core part: Enhanced Broadcast of System Information | 174.8d? | 2013-12-06 A | 2014-09-12 A | 100% |  | 2013-12-06 | 2014-09-12 | 174.8d? |  | finish no earlier than 2014-09-12 | R2; R1; R3; R4 | 5593.6h | 5593.6h | UTRA_SIBenh-Core | 32 | Ericsson | martin.van.der.zee@ericsson.com | Rel-12 | 62 | Yong-Jun | UTRA_SIBenh-Core | RP-141230 |  |  |  |
| 5374 | 1727.2 | Perf. part: Enhanced Broadcast of System Information | 265d? | 2013-12-15 A | 2014-12-15 A | 100% |  | 2013-12-09 | 2014-12-05 | 261d? |  | finish no earlier than 2014-12-15 | R4 | 2120h | 2120h | UTRA_SIBenh-Perf | 32 | Ericsson | martin.van.der.zee@ericsson.com | Rel-12 | 62 | Issam | UTRA_SIBenh-Perf | RP-142080 |  |  |  |
| 5375 | 1728 | **Further Enhanced Uplink (EUL) enhancements** | 329d? | 2013-12-15 A | 2015-03-13 A | 100% |  | 2013-12-09 | 2014-12-05 | 261d? |  |  | R2 | 13704h | 13704h | EDCH_enh | 32 | Ericsson | mark.curran@ericsson.com | Rel-12 | 62 | Yong-Jun | EDCH_enh |  |  |  |  |
| 5376 | 1728.1 | Core part: Further Enhanced Uplink (EUL) enhancements | 264d? | 2013-12-15 A | 2014-12-15 A | 100% |  | 2014-04-29 | 2014-09-12 | 99d? |  | finish no earlier than 2014-12-15 | R2; R1; R3; R4 | 8448h | 8448h | EDCH_enh-Core | 32 | Ericsson | mark.curran@ericsson.com | Rel-12 | 62 | Yong-Jun | EDCH_enh-Core | RP-141860 |  |  |  |
| 5377 | 1728.2 | Perf. part: Further Enhanced Uplink (EUL) enhancements | 328d? | 2013-12-15 A | 2015-03-13 A | 100% |  | 2013-12-09 | 2014-12-05 | 261d? |  | finish no earlier than 2015-03-15 | R4 | 2624h | 2624h | EDCH_enh-Perf | 32 | Ericsson | mark.curran@ericsson.com | Rel-12 | 62 | Issam | EDCH_enh-Perf | RP-150062 |  |  |  |
| 5378 | 1729 | (Small) Technical Enhancements and Improvements for Rel-12 | 197.5d? | 2012-12-25 A | 2014-09-16 A | 100% |  | 2012-12-25 | 2014-09-17 | 197.5d? |  | finish no earlier than 2014-09-17 | SP; CP; RP; GP | 6320h | 6320h | TEI12 | 29 |  |  | Rel-12 | 56 |  | TEI12 |  |  |  |  |
| 5379 | 1730 | (IETF) (Small) Technical Enhancements and Improvements for Rel-12 (draft-ietf-insipid-session-id) | 131d? | 2014-06-13 A | 2014-12-09 A | 100% |  |  |  |  |  | start no earlier than 2014-06-13 | C1-IETF | 1048h | 1048h | TEI12_IETF | 34 | Alcatel-Lucent |  | Rel-12 | 66 |  |  |  |  |  |  |
| 5380 | 1731 | Test - (Small) Technical Enhancements and Improvements for Rel-12 | 295.5d? | 2014-10-24 A | 2015-12-11 A | 100% |  | 2014-10-24 | 2015-12-11 | 295.5d? |  | finish no earlier than 2015-12-11 | R5; G3new | 4728h | 4728h | TEI12_Test | 31 |  |  | Rel-12 | 61 | Ingbert | TEI12_Test |  |  |  |  |
| 5381 | 1732 | Release 12 Studies | 296.5d? | 2013-08-05 A | 2014-09-16 | 80% | 59.3d? | 2013-08-05 | 2014-09-17 | 296.5d? | 2997d | finish no earlier than 2014-09-17 | SP; CP; GP; RP | 9488h | 7590.4h |  |  |  |  | Rel-12 |  |  |  |  |  |  |  |
| 5382 | 1733 | Study on Alternatives to E.164 for Machine-Type Communications | 513d? | 2010-03-25 A | 2012-03-07 A | 100% |  | 2010-03-25 | 2012-03-07 | 513d? |  | finish no earlier than 2012-03-07 | S1 | 4080h | 4080h | FS_AMTC | 24 | T-Mobile USA | gary.jones@T-Mobile.com | Rel-12 | 47 | Alain | FS_AMTC |  | MTC, M2M |  |  |
| 5383 | 1734 | Study on enhancements for Machine-Type Communications (MTC) | 720d? | 2010-06-10 A | 2013-03-06 A | 100% |  | 2010-06-10 | 2013-03-06 | 720d? |  | finish no earlier than 2013-03-06 | S1 | 5751.26h | 5751.26h | FS_MTCe | 25 | Huawei | laurence.meriau@huawei.com | Rel-12 | 48 | Alain | FS_MTCe |  | MTC, M2M |  |  |
| 5384 | 1735 | Study on Integration of Single Sign-On (SSO) frameworks with 3GPP networks | 383d? | 2010-09-23 A | 2012-03-07 A | 100% |  | 2010-09-23 | 2012-03-07 | 383d? |  | finish no earlier than 2011-09-08 | S1 | 3041.15h | 3041.15h | FS_SSO_Int | 25 | InterDigital | christopher.wallace@interdigital.com | Rel-12 | 49 | Alain | FS_SSO_Int |  |  |  |  |
| 5385 | 1736 | Study on Continuity of Data Sessions to Local Networks | 262.85d? | 2010-12-16 A | 2011-12-14 A | 100% |  | 2010-12-16 | 2011-12-14 | 262.85d? |  | finish no earlier than 2011-12-14 | S1 | 2084.27h | 2084.27h | FS_CSN | 26 | NEC | joerg.swetina@neclab.eu | Rel-12 | 50 | Alain | FS_CSN |  |  |  |  |
| 5386 | 1737 | Study on non-MTC Mobile Data Applications Impacts | 262.77d? | 2010-12-16 A | 2011-12-14 A | 100% |  | 2010-12-16 | 2011-12-14 | 262.77d? |  | finish no earlier than 2011-12-14 | S1 | 2083.59h | 2083.59h | FS_MODAI | 26 | Huawei, China Mobile | Amar Deol (adeol@huawei.com), Gang Li | Rel-12 | 50 | Alain | FS_MODAI |  |  |  |  |
| 5387 | 1738 | Study on Proximity-based Services | 384d? | 2011-09-22 A | 2013-03-05 A | 100% |  | 2011-09-22 | 2013-03-05 | 384d? |  | finish no earlier than 2012-12-12 | S1 | 3045.82h | 3045.82h | FS_ProSe | 27 | Qualcomm | Rich Hovey (rhovey@qualcomm.com) | Rel-12 | 53 | Alain | FS_ProSe |  | Public Safety (A-A) |  |  |
| 5388 | 1739 | Study on User Plane Congestion management | 198d? | 2011-12-14 A | 2012-09-12 A | 100% |  | 2011-12-14 | 2012-09-12 | 198d? |  | finish no earlier than 2012-09-12 | S1 | 1568h | 1568h | FS_UPCON | 28 | KDDI | John Visser (jvisser@rogers.com) | Rel-12 | 54 | Alain | FS_UPCON |  |  |  |  |
| 5389 | 1740 | Study on RAN Sharing Enhancements | 401d? | 2011-12-14 A | 2013-06-19 A | 100% |  | 2011-12-14 | 2013-06-19 | 401d? |  | finish no earlier than 2013-06-19 | S1 | 3192h | 3192h | FS_RSE | 28 | NEC | joerg.swetina@neclab.eu | Rel-12 | 54 | Alain | FS_RSE |  |  |  |  |
| 5390 | 1741 | Deleted - Study on UICC/USIM enhancements | 588d? | 2009-12-10 A | 2012-03-07 A | 100% |  | 2009-12-10 | 2012-03-07 | 588d? |  | finish no earlier than 2012-03-07 | S1 | 4704h | 4704h | FS_U2e | 24 | Giesecke & Devrient | ilario.macchi@gi-de.com | Rel-12 | 46 | Alain | FS_U2e |  |  | PCG-28 | SP-55 |

Notes:
- 5362: Triggered by Rel-12 TR 25.702 Study on Dedicated Channel (DCH) enhancements for UMTS (FS_UTRA_DCHenh) UID_580040. Stage 2/3 / Impacted TSs and TRs: UTRA
- 5363: RP#65 completed / Impacted TSs and TRs: 25.101; 25.104; 25.133; 25.211; 25.212; 25.213; 25.214; 25.215; 25.306; 25.308; 25.321; 25.331; 25.423; 25.433
- 5364: ¦Stat Rep: RP-141137->RP-141970 / Impacted TSs and TRs: 25.101; 25.104; 25.133
- 5365: 03/07/15: Compl:0%->15% 03/07/15: Stat Rep: ->RP-150764 29/09/15: Compl:15%->50% 29/09/15: CD:Tue 15/12/15->Wed 15/06/16 29/09/15: Stat Rep: RP-150764->RP-1512791/1/16: Compl:50%->65%;
- 5366: Triggered by Rel-12 TR 25.800 Study on UMTS heterogeneous networks (FS_UTRA_hetnet) UID_570024. Stage 2/3 / Impacted TSs and TRs: UTRA
- 5367: RP#64 completed. TS 25.300v100 for 1-step Approval / Impacted TSs and TRs: 25.101; 25.104; 25.133; 25.141; 25.304; 25.306; 25.331; 25.433; new 25.300
- 5368: RP#64 completed / Impacted TSs and TRs: 25.101; 25.104; 25.133; 25.141
- 5369: Triggered by the 2nd part of TR 25.800 (FS_UTRA_HetNet)¦the 1st part is addressed by UTRA_HetNet_mob UID_610026 / Impacted TSs and TRs: UTRA
- 5370: RP#65 completed. Updated WID RP-140463=>RP-141701 / Impacted TSs and TRs: 25.101; 25.211; 25.212; 25.213; 25.214; 25.300; 25.302; 25.306; 25.308; 25.319; 25.331; 25.423; 25.433
- 5371: ¦Stat Rep: RP-141702->RP-141898 / Impacted TSs and TRs: 25.101; 25.104; 25.133; 25.141
- 5372: Triggered by Rel-12 UTRA TR 25.704 Study on Enhanced Broadcast of System Information (FS_UTRA_SIBenh) / Impacted TSs and TRs: UTRA
- 5373: RP#65 completed / Impacted TSs and TRs: 25.211; 25.212 ; 25.213; 25.214; 25.301; 25.302; 25.304; 25.306; 25.321; 25.331; 25.433
- 5374: ¦Stat Rep: RP-141230->RP-142080 / Impacted TSs and TRs: 25.101; 25.104; 25.133; 25.141
- 5375: Triggered by Rel-12 UTRA TR 25.700 Study on Further Enhanced Uplink (EUL) enhancements (FS_EDCH_enh) / Impacted TSs and TRs: UTRA
- 5376: ¦Stat Rep: RP-141684->RP-141860 / Impacted TSs and TRs: 25.211; 25.212; 25.214; 25.304; 25.306; 25.308; 25.319; 25.321; 25.331; 25.423; 25.425; 25.433; 25.435
- 5377: ¦CD:Wed 18/03/15->Sun 15/03/15¦Stat Rep: RP-141684->RP-141860 1st Apr 15: Compl:75%->100% 1st Apr 15: Stat Rep: RP-141860->RP-150062 / Impacted TSs and TRs: 25.101; 25.104; 25.133; 25.141
- 5378: -
- 5379: Mar15: In WGLC¦21/3/17: 50%->100; 9/4/21: RFC 7989 added; / Impacted TSs and TRs: draft-ietf-insipid-session-id; RFC 7989
- 5380: -
- 5381: -
- 5382: SP#55 completed. Determine an alternative to E.164 for identifying individual devices and route messages between those devices / Impacted TSs and TRs: 22.988
- 5383: SP#59 completed. TR 22.888 v100 for Information & Approval. Study addition of new MTC-related use cases and functionality and improvements to existing requirements in TS 22.368 / Impacted TSs and TRs: 22.888
- 5384: SP#55 completed. Linked to SA3 Study on Single Sign On (SSO) Application Security for IMS - based on SIP Digest (UID_480048), SA3 TR 33.924 Extended Identity Management (GBA-IdM) and SA3 TR 33.980 (LibSec) / Impacted TSs and TRs: 22.895
- 5385: SP#54 completed. Linked to SA1 Rel-11 Feature UID_490030 SIPTO Service Continuity of IP Data Session (SIPTO_SC) / Impacted TSs and TRs: 22.896
- 5386: SP#54 completed. Linked to UID_490036 SA2 Rel-11 TR 23.843 Study on Core Network Overload solutions (FS_CNO) / Impacted TSs and TRs: 22.801
- 5387: SP#59 completed / Impacted TSs and TRs: 22.803
- 5388: SP#57 completed. Linked to SAPP (Service Awareness and Privacy Policies), FS_UMONC (Study on Usage Monitoring Control Enhancement), QoS_SSL (QoS Control Based on Subscriber Spending Limits) / Impacted TSs and TRs: 22.805
- 5389: SP#60 completed. Extend Rel-6 Network Sharing UID_31018 (basic scenarios of network/RAN sharing) to cover more complex scenarios that arise due to recent needs for more dynamic co-operation among operators / Impacted TSs and TRs: 22.852
- 5390: SP#55 work stopped. Triggered by GSMA Smart SIM and 3GNBK projects, and to evolve from traditional USAT to multimedia USIM toolkit support, particularly to Smart Card Web Server / Impacted TSs and TRs: 22.817

| ID | WBS | Task | Duration | Start | Finish | Complete | Baseline start | Baseline finish | Baseline duration | Constraint | Resources | Work | Actual work | Acronym | PCG approved | Impacted TSs and TRs | WI rapporteur name | WI rapporteur e-mail | Release | TSG approved | MCC resp | Acronym_3GU_Export | Special Focus Doc | PCG stopped | TSG stopped | Status Report |
| --- | --- | --- | --- | --- | --- | --- | --- | --- | --- | --- | --- | --- | --- | --- | --- | --- | --- | --- | --- | --- | --- | --- | --- | --- | --- | --- |
| 5391 | 1742 | **Study on IMS based Peer-to-Peer Content Distribution Services (Stage 2)** | 587d? | 2010-09-23 A | 2012-12-12 A | 100% | 2010-09-23 | 2012-12-12 | 587d? |  | S2; S1; S3 | 19472h | 19472h | FS_IMS_P2P_CDS | 25 | 23.844 | China Mobile | Yu Qing (yuqing@chinamobile.com) | Rel-12 | 49 | Maurice | FS_IMS_P2P_CDS |  |  |  |  |
| 5392 | 1742.1 | SA1 part of Study on IMS based Peer-to-Peer Content Distribution Services (Stage 2) | 262d? | 2010-09-23 A | 2011-09-21 A | 100% | 2010-09-23 | 2011-09-21 | 262d? | finish no earlier than 2011-09-21 | S1 | 2080h | 2080h | FS_IMS_P2P_CDS | 25 | 23.844 | China Mobile | Yu Qing (yuqing@chinamobile.com) | Rel-12 | 49 | Maurice |  |  |  |  |  |
| 5393 | 1742.2 | SA2 part of Study on IMS based Peer-to-Peer Content Distribution Services (Stage 2) | 347d? | 2010-09-23 A | 2012-06-20 A | 100% | 2010-09-23 | 2012-06-20 | 347d? | finish no earlier than 2012-06-08 | S2 | 2776h | 2776h | FS_IMS_P2P_CDS | 25 | 23.844 | China Mobile | Yu Qing (yuqing@chinamobile.com) | Rel-12 | 49 | Maurice |  |  |  |  |  |
| 5394 | 1742.3 | SA3 part of Study on IMS based Peer-to-Peer Content Distribution Services (Stage 2) | 68d? | 2012-09-12 A | 2012-12-12 A | 100% | 2012-09-12 | 2012-12-12 | 68d? | finish no earlier than 2012-12-12 | S3 | 528h | 528h | FS_IMS_P2P_CDS | 29 | 33.844 | China Mobile | Zhu Judy(zhuhongru@chinamobile.com) | Rel-12 | 57 | Mirko |  |  |  |  |  |
| 5395 | 1743 | **Study on Core Network Overload solutions** | 852d? | 2010-09-23 A | 2013-12-11 A | 100% | 2010-09-23 | 2013-12-11 | 852d? |  | S2 | 18240.6h | 18240.6h | FS_CNO | 25 | 23.843 | Huawei | Mirko.Schramm@huawei.com | Rel-12 | 49 | Maurice | FS_CNO |  |  |  |  |
| 5396 | 1743.1 | Study on Core Network Overload solutions (Phase 1) | 587d? | 2010-09-23 A | 2012-12-12 A | 100% | 2010-09-23 | 2012-12-12 | 587d? | finish no earlier than 2012-12-12 | S2 | 4684.11h | 4684.11h | FS_CNO | 25 | 23.843 | Huawei | Mirko.Schramm@huawei.com | Rel-12 | 49 | Maurice |  |  |  |  |  |
| 5397 | 1743.2 | Study on Core Network Overload solutions (Phase 2) | 844d? | 2010-09-23 A | 2013-12-11 A | 100% | 2010-09-23 | 2013-12-11 | 844d? | finish no earlier than 2013-12-11 | S2 | 6744h | 6744h | FS_CNO | 25 | 23.843 | Huawei | Mirko.Schramm@huawei.com | Rel-12 | 49 | Maurice |  |  |  |  |  |
| 5398 | 1744 | Study on System Enhancements for Energy Efficiency | 399d? | 2010-12-16 A | 2012-06-20 A | 100% | 2010-12-16 | 2012-06-20 | 399d? | finish no earlier than 2012-06-20 | S2 | 3192h | 3192h | FS_SEEE | 26 | 23.866 | Huawei | frank.mademann@huawei.com | Rel-12 | 50 | Maurice | FS_SEEE |  |  |  |  |
| 5399 | 1745 | Study on S2a Mobility based On GTP and WLAN access to EPC | 657d? | 2011-03-23 A | 2013-09-11 A | 100% | 2011-03-23 | 2013-09-11 | 657d? | finish no earlier than 2013-09-11 | S2 | 5165.94h | 5165.94h | FS_SaMOG | 26 | 23.852 | ZTE | Tricci So (tso@zteusa.com) | Rel-12 | 51 | Maurice | FS_SaMOG | WLAN |  |  |  |
| 5400 | 1746 | Study on Optimized Offloading to WLAN in 3GPP-RAT Mobility | 326d? | 2012-06-18 A | 2013-09-11 A | 100% | 2012-06-18 | 2013-09-11 | 326d? | finish no earlier than 2013-09-11 | S2 | 2592h | 2592h | FS_WORM | 29 | 23.890 | BlackBerry | Steve Barrett (sbarrett@blackberry.com) | Rel-12 | 56 | Maurice | FS_WORM | WLAN |  |  |  |
| 5401 | 1747 | Study on Application Based Charging | 190d? | 2012-06-18 A | 2013-03-06 A | 100% | 2012-06-18 | 2013-03-06 | 190d? | finish no earlier than 2013-03-06 | S2 | 1520h | 1520h | FS_ABC | 29 | 23.800 | Allot | Alla Goldner (agoldner@allot.com) | Rel-12 | 56 | Maurice | FS_ABC |  |  |  |  |
| 5402 | 1748 | **Study on Multi Access PDN connectivity and IP flow Mobility** | 1141.96d? | 2008-08-08 A | 2012-12-12 A | 100% | 2008-08-08 | 2012-12-12 | 1141.96d? |  | S2; S1 | 27327.4h | 27327.4h | FS_MAPIM | 21 | 23.861 | Qualcomm | Gerardo Giaretta (gerardog@qualcomm.com) | Rel-12 | 41 | Maurice | FS_MAPIM |  |  |  |  |
| 5403 | 1748.1 | SA1 part of Study on Multi Access PDN connectivity and IP flow Mobility | 22d? | 2008-08-08 A | 2011-09-21 A | 100% | 2008-08-08 | 2011-09-21 | 22d? | finish no earlier than 2011-09-21 | S1 | 160h | 160h | FS_MAPIM | 21 | 23.861 | Qualcomm | Gerardo Giaretta (gerardog@qualcomm.com) | Rel-12 | 41 | Maurice |  |  |  |  |  |
| 5404 | 1748.2 | SA2 part of Study on Multi Access PDN connectivity and IP flow Mobility | 1113d? | 2008-09-18 A | 2012-12-12 A | 100% | 2008-09-18 | 2012-12-12 | 1113d? | finish no earlier than 2012-12-12 | S2 | 8896h | 8896h | FS_MAPIM | 21 | 23.861 | Qualcomm | Gerardo Giaretta (gerardog@qualcomm.com) | Rel-12 | 41 | Maurice |  |  |  |  |  |
| 5405 | 1749 | Deleted - Study on IP Flow Mobility support for S2a and S2b Interfaces | 190d? | 2012-06-18 A | 2013-03-06 A | 100% | 2012-06-18 | 2013-03-06 | 190d? | finish no earlier than 2013-03-06 | S2 | 1520h | 1520h | FS_NBIFOM | 29 | 23.861 | ZTE | Tricci So (tso@zteusa.com) | Rel-12 | 56 | Maurice | FS_NBIFOM |  | PCG-30 | SP-59 |  |
| 5406 | 1750 | Study on Extended IMS Media Plane Security features | 719d? | 2010-06-10 A | 2013-03-06 A | 100% | 2010-06-10 | 2013-03-06 | 719d? | finish no earlier than 2013-03-06 | S3 | 5736h | 5736h | FS_eMEDIASEC | 25 | 33.829 | Vodafone | Aguibou.Barry@vodafone.com | Rel-12 | 48 | Mirko | FS_eMEDIASEC |  |  |  |  |
| 5407 | 1751 | Deleted - Study on Firewall traversal (Stage 2) | 854d? | 2011-06-17 A | 2014-09-17 A | 100% | 2011-06-17 | 2014-09-17 | 854d? | finish no earlier than 2014-09-17 | S3 | 6832h | 6832h | FS_Fire | 27 | 33.830 | Acme Packet | Prashant Kumar (PKumar@acmepacket.com) | Rel-12 | 53 | Mirko | FS_Fire |  | PCG-33 | SP-65 |  |
| 5408 | 1752 | Study on Security on spoofed call detection and prevention (Stage 2) | 662d? | 2012-03-07 A | 2014-09-17 A | 100% | 2012-03-07 | 2014-09-17 | 662d? | finish no earlier than 2014-09-17 | S3 | 5296h | 5296h | FS_SPOOF | 28 | 33.831 | China Mobile | lixiangjun@chinamobile.com | Rel-12 | 55 | Mirko | FS_SPOOF |  |  |  |  |
| 5409 | 1753 | Study on Security Assurance Methodology for 3GPP Network Elements | 466d? | 2012-09-13 A | 2014-06-18 A | 100% | 2012-09-13 | 2014-06-18 | 466d? | finish no earlier than 2014-03-07 | S3 | 3696h | 3696h | FS_SECAM | 29 | 33.805 | Orange | loic.habermacher@orange.com | Rel-12 | 57 | Mirko | FS_SECAM |  |  |  |  |
| 5410 | 1754 | Study on Improved Support for Dynamic Adaptive Streaming over HTTP in 3GPP | 729d? | 2011-12-14 A | 2014-09-16 A | 100% | 2011-12-14 | 2014-09-17 | 729d? | finish no earlier than 2014-09-17 | S4 | 5824h | 5824h | FS_IS_DASH | 28 | 26.938 | Qualcomm | c_tstock@qualcomm.com | Rel-12 | 54 | Paolo | FS_IS_DASH |  |  |  |  |
| 5411 | 1755 | Study on HTML5 for a new presentation layer in 3GPP services | 266d? | 2013-09-12 A | 2014-09-16 A | 100% | 2013-09-12 | 2014-09-17 | 266d? | finish no earlier than 2014-09-17 | S4 | 2128h | 2128h | FS_HTML5 | 31 | 26.907 | Samsung | Imed Bouazizi (i.bouazizi@sta.samsung.com) | Rel-12 | 61 | Paolo | FS_HTML5 |  |  |  |  |
| 5412 | 1756 | Study on version handling | 716d? | 2010-03-25 A | 2012-12-12 A | 100% | 2010-03-25 | 2012-12-12 | 716d? | finish no earlier than 2012-12-12 | S5 | 5704h | 5704h | FS_OAM_VH | 24 | 32.830 | Ericsson | thomas.tovinger@ericsson.com | Rel-12 | 47 | Mirko | FS_OAM_VH |  |  |  |  |
| 5413 | 1757 | Study on management of Heterogeneous Networks | 852d? | 2011-03-23 A | 2014-06-18 A | 100% | 2011-03-23 | 2014-06-18 | 852d? | finish no earlier than 2014-06-18 | S5 | 6816h | 6816h | FS_OAM_HetNet | 26 | 32.835 | Ericsson | ulf.hubinette@ericsson.com | Rel-12 | 51 | Mirko | FS_OAM_HetNet |  |  |  |  |
| 5414 | 1758 | Study on OAM aspects of Network Sharing | 464d? | 2011-12-07 A | 2013-09-11 A | 100% | 2011-12-07 | 2013-09-11 | 464d? | finish no earlier than 2013-09-11 | S5 | 3696h | 3696h | FS_OAM_SHARE | 28 | 32.851 | Alcatel-Lucent, Huawei | Padma.Sudarsan@alcatel-lucent.com, zoulan@huawei.com | Rel-12 | 54 | Mirko | FS_OAM_SHARE |  |  |  |  |
| 5415 | 1759 | Study on Enhanced Network Management (NM) centralized Coverage and Capacity Optimization | 590d? | 2011-09-21 A | 2014-09-17 A | 100% | 2011-09-21 | 2014-09-17 | 590d? | finish no earlier than 2014-09-17 | S5 | 4712h | 4712h | FS_SON_NM_CCO | 29 | 32.836 | Ericsson | robert.petersen@ericsson.com | Rel-12 | 56 | Mirko | FS_SON_NM_CCO | SON |  |  |  |
| 5416 | 1760 | Study on WLAN management | 788d? | 2011-09-21 A | 2014-09-17 A | 100% | 2012-06-20 | 2014-09-17 | 590d? | finish no earlier than 2014-09-17 | S5 | 6304h | 6304h | FS_WLAN_OAM | 29 | 28.680; 28.681; 28.682; 28.683; 28.403 | Intel | joey.chou@intel.com | Rel-12 | 56 | Mirko | FS_WLAN_OAM | WLAN |  |  |  |
| 5417 | 1761 | Study on Alarm Management | 201d? | 2012-12-07 A | 2013-09-11 A | 100% | 2012-12-07 | 2013-09-11 | 201d? | finish no earlier than 2013-09-11 | S5 | 1592h | 1592h | FS_OAM_AM | 30 | 32.859 | TeliaSonera | tommy.berggren@teliasonera.com | Rel-12 | 58 | Mirko | FS_OAM_AM |  |  |  |  |
| 5418 | 1762 | Study on Indication of Network to Network Interface (NNI) Routeing scenarios in SIP requests | 400d? | 2012-12-10 A | 2014-06-13 A | 100% | 2012-12-10 | 2014-06-13 | 400d? | finish no earlier than 2014-03-06 | C3 | 3190.27h | 3190.27h | FS_NNI_RS | 30 | 24.802 | Ericsson | Jan.Holm@ericsson.com | Rel-12 | 58 | Adrian | FS_NNI_RS |  |  |  |  |
| 5419 | 1763 | Study on Diameter Overload Control Mechanisms | 464d? | 2012-01-05 A | 2014-09-11 A | 100% | 2012-01-05 | 2014-09-12 | 464d? | finish no earlier than 2014-09-12 | C4 | 3712h | 3712h | FS_DOCME | 30 | 29.809 | Orange | lionel.morand@orange.com | Rel-12 | 58 | Kimmo | FS_DOCME |  |  |  |  |
| 5420 | 1764 | Study on XML based access of AF to the PCRF | 203d? | 2013-03-01 A | 2013-12-04 A | 100% | 2013-03-01 | 2014-06-13 | 341d? | finish no earlier than 2014-06-13 | C3 | 1608h | 1608h | FS_XML_AF_PCRF | 30 | 29.817 | Alcatel-Lucent | horst.brinkman@alcatel-lucent.com | Rel-12 | 59 | Adrian | FS_XML_AF_PCRF |  |  |  |  |
| 5421 | 1765 | Study on Technical aspects on Roaming End-to-end scenarios with VoLTE IMS and other networks | 328d? | 2013-09-09 A | 2014-12-09 A | 100% | 2013-09-09 | 2014-09-12 | 266d? | finish no earlier than 2014-12-09 | C3 | 2624h | 2624h | FS_REVOLTE_IMS | 31 | 29.949 | Deutsche Telekom | Roland Jesske (r.jesske@telekom.de) | Rel-12 | 61 | Adrian | FS_REVOLTE_IMS |  |  |  |  |
| 5422 | 1766 | Study on Development of conformance requirements for the IP Multimedia Services Identity Module (ISIM) application support in ME | 263d? | 2013-12-09 A | 2014-12-09 A | 100% | 2013-12-09 | 2014-09-12 | 201d? | finish no earlier than 2014-12-09 | C6 | 2104h | 2104h | FS_ISIM_CR | 32 | 31.829 | Gemalto | ly-thanh.phan@gemalto.com | Rel-12 | 62 | Xavier | FS_ISIM_CR |  |  |  |  |
| 5423 | 1767 | Study on Shared Data Update for Multiple Subscribers | 263d? | 2013-12-06 A | 2014-12-09 A | 100% | 2013-12-06 | 2014-09-12 | 201d? | finish no earlier than 2014-12-09 | C4 | 2104h | 2104h | FS_SHARED_SubData_UPD | 32 | 29.854 | Huawei | Susan Shi (susan.shishufeng@huawei.com) | Rel-12 | 62 | Kimmo | FS_SHARED_SubData_UPD |  |  |  |  |
| 5424 | 1768 | Study on GERAN improvements for Machine-Type Communications | 661d? | 2010-05-24 A | 2012-11-23 A | 100% | 2010-05-24 | 2012-11-23 | 661d? | finish no earlier than 2012-11-23 | G1; G2 | 10576h | 10576h | FS_NIMTC_GERAN | 24 | 43.868 | Ericsson | paul.schliwa-bertling@ericsson.com | Rel-12 | 44 | Paolo | FS_NIMTC_GERAN | MTC, M2M |  |  |  |
| 5425 | 1769 | Study on Voice services over Adaptive Multi-user channels on One Slot (VAMOS) enhancements | 267.67d? | 2010-10-27 A | 2014-05-30 A | 100% | 2010-10-27 | 2014-05-30 | 267.67d? | finish no earlier than 2014-05-30 | GP; G2; G1 | 6424h | 6424h | FS_eVAMOS | 27 | 43.801 | China Mobile, Huawei | Chao Luo (chluo@huawei.com), dengjuan@chinamobile.com | Rel-12 | 50 | Paolo | FS_eVAMOS |  |  |  |  |
| 5426 | 1770 | Study on GERAN enhancements for Mobile Data Applications | 430d? | 2011-04-04 A | 2014-08-29 A | 100% | 2011-04-04 | 2014-08-29 | 430d? | finish no earlier than 2014-08-29 | G2; G1 | 6880h | 6880h | FS_GERAN_eMDA | 27 | 43.802 | Huawei | ming.fang@huawei.com | Rel-12 | 50 | Gert | FS_GERAN_eMDA |  |  |  |  |
| 5427 | 1771 | Study on Inclusion of RF Pattern Matching Technologies as a positioning method in the E-UTRAN | 722d? | 2010-12-10 A | 2013-09-06 A | 100% | 2010-12-10 | 2013-09-06 | 722d? | finish no earlier than 2013-09-06 | R4 | 5776h | 5776h | FS_LCS_LTE_RFPMT | 26 | LTE 36.809 | Polaris Wireless | Scot Gordon (sgordon@polariswireless.com) | Rel-12 | 50 | Issam | FS_LCS_LTE_RFPMT |  |  |  | RP-131082 |
| 5428 | 1772 | Study on Provision of low-cost MTC UEs based on LTE | 462d? | 2011-09-19 A | 2013-06-14 A | 100% | 2011-09-19 | 2013-06-14 | 462d? | finish no earlier than 2013-06-14 | R1; R2; R4 | 11088h | 11088h | FS_LC_MTC_LTE | 27 | LTE 36.888 | Vodafone | prakash.bhat@vodafone.com | Rel-12 | 53 | Patrick | FS_LC_MTC_LTE | MTC, M2M |  |  | RP-130583 |
| 5429 | 1773 | Deleted - Study on Mobile Relay for E-UTRA | 881.5d? | 2005-05-19 A | 2014-06-23 A | 100% | 2005-05-19 | 2014-06-23 | 881.5d? | finish no earlier than 2014-06-23 | R3; R1 | 14104h | 14104h | FS_LTE_mobRelay | 27 | LTE 36.836 | CATT | Haijing Hu (huhaijing@catt.cn) | Rel-12 | 53 | Juha | FS_LTE_mobRelay |  | PCG-33 | RP-64 | RP-140726 |
| 5430 | 1774 | Study on Scenarios and Requirements of LTE Small Cell Enhancements for E-UTRA and E-UTRAN | 66d? | 2012-09-11 A | 2012-12-07 A | 100% | 2012-09-11 | 2012-12-07 | 66d? | finish no earlier than 2012-12-07 | RP | 528h | 528h | FS_LTE_SC_enh_req | 29 | LTE 36.932 | China Mobile | Hai TANG (tanghai@chinamobile.com) | Rel-12 | 57 | Yong-Jun | FS_LTE_SC_enh_req | Small cell |  |  | RP-121651 |
| 5431 | 1775 | Study on Small Cell Enhancements for E-UTRA and E-UTRAN – Physical-layer aspects | 265d? | 2012-09-11 A | 2013-09-06 A | 100% | 2012-09-11 | 2013-09-06 | 265d? | finish no earlier than 2013-09-06 | R1; R2; R4 | 6360h | 6360h | FS_LTE_SC_enh_L1 | 30 | LTE 36.872 | Huawei | Elean Fan (fanxiaoan@huawei.com) | Rel-12 | 58 | Patrick | FS_LTE_SC_enh_L1 | Small cell |  |  | RP-131618 |
| 5432 | 1776 | Study on Small Cell Enhancements for E-UTRA and E-UTRAN – Higher-layer aspects | 265d? | 2012-12-10 A | 2013-12-06 A | 100% | 2012-12-10 | 2013-12-06 | 265d? | finish no earlier than 2013-12-06 | R2; R3 | 4240h | 4240h | FS_LTE_SC_enh_hilayer | 30 | LTE 36.842 | NTT DOCOMO | Hideaki Takahashi (h-takahashi@nttdocomo.co.jp) | Rel-12 | 58 | Yong-Jun | FS_LTE_SC_enh_hilayer | Small cell |  |  | RP-131619 |
| 5433 | 1777 | Study on LTE Device-to-Device Proximity Services - Radio Aspects | 325d? | 2012-12-17 A | 2014-03-06 A | 100% | 2012-12-17 | 2014-03-06 | 325d? | finish no earlier than 2014-03-06 | R1; R2; R3; R4 | 10400h | 10400h | FS_LTE_D2D_Prox | 30 | LTE 36.843 | Qualcomm | Shailesh Patil (patil@qti.qualcomm.com) | Rel-12 | 58 | Patrick | FS_LTE_D2D_Prox | Public Safety (A-A) |  |  | RP-140416 |
| 5434 | 1778 | Study on 3D-channel model for Elevation Beamforming and FD-MIMO studies for LTE | 463d? | 2012-12-10 A | 2014-09-12 A | 100% | 2012-12-10 | 2014-09-12 | 463d? | finish no earlier than 2014-09-12 | R1 | 3704h | 3704h | FS_LTE_3D_channel | 30 | LTE 36.873 | Nokia Networks | bishwarup.mondal@nsn.com | Rel-12 | 58 | Patrick | FS_LTE_3D_channel |  |  |  | RP-141206 |
| 5435 | 1779 | Study on Energy Saving Enhancement for E-UTRAN | 397d? | 2012-12-10 A | 2014-06-13 A | 100% | 2012-12-10 | 2014-06-13 | 397d? | finish no earlier than 2014-06-13 | R3 | 3176h | 3176h | FS_Netw_Energy_enh_LTE | 30 | LTE 36.887 | China Mobile | Kimba Dit Adamou, Boubacar (jinba@chinamobile.com) | Rel-12 | 58 | Juha | FS_Netw_Energy_enh_LTE |  |  |  | RP-140604 |
| 5436 | 1780 | Study on Expansion of LTE_FDD_1670_US to include 1670-1680MHz Band for LTE in the US | 469d? | 2013-03-01 A | 2014-12-15 A | 100% | 2013-03-01 | 2014-09-12 | 403d? | finish no earlier than 2014-12-15 | R4 | 3752h | 3752h | FS_LTE_FDD_1670_US | 30 | LTE 36.844 | LightSquared | masoud.olfat@lightsquared.com | Rel-13 | 59 | Issam | FS_LTE_FDD_1670_US |  |  |  | RP-141815 |
| 5437 | 1781 | Study on Cell-specific Reference Signals (CRS) Interference Mitigation for homogenous deployments for LTE | 201d? | 2013-03-04 A | 2013-12-06 A | 100% | 2013-03-04 | 2013-12-06 | 201d? | finish no earlier than 2013-12-06 | R4 | 1608h | 1608h | FS_LTE_CRSIC | 30 | LTE 36.863 | Ericsson | shaohua.li@ericsson.com | Rel-12 | 59 | Issam | FS_LTE_CRSIC |  |  |  | RP-131623 |
| 5438 | 1782 | Study on Network-Assisted Interference Cancellation and Suppression for LTE | 265d? | 2013-03-08 A | 2014-03-06 A | 100% | 2013-03-08 | 2014-03-06 | 265d? | finish no earlier than 2014-03-06 | R1; R4 | 4240h | 4240h | FS_LTE_NAICS | 30 | LTE 36.866 | MediaTek | jeff.zhuang@mediatek.com | Rel-12 | 59 | Patrick | FS_LTE_NAICS |  |  |  | RP-132108 |
| 5439 | 1783 | Study on Coordinated Multi-Point (CoMP) operation for LTE with Non-Ideal Backhaul | 126d? | 2013-06-18 A | 2013-12-06 A | 100% | 2013-06-18 | 2013-12-06 | 126d? | finish no earlier than 2013-12-06 | R1 | 1008h | 1008h | FS_COMP_LTE_nibackhaul | 31 | LTE 36.874 | Samsung | Hyojin Lee (hyojin257.lee@samsung.com) | Rel-12 | 60 | Patrick | FS_COMP_LTE_nibackhaul |  |  |  | RP-131626 |
| 5440 | 1784 | Study on Group Communication for LTE | 130d? | 2013-09-10 A | 2014-03-06 A | 100% | 2013-09-10 | 2014-03-06 | 130d? | finish no earlier than 2014-03-06 | R2; R3 | 2080h | 2080h | FS_LTE_GC | 31 | LTE 36.868 | Alcatel-Lucent | chandrika.worrall@alcatel-lucent.com | Rel-12 | 61 | Yong-Jun | FS_LTE_GC | Public Safety (A-A) |  |  | RP-140182 |
| 5441 | 1785 | Study on Smart Congestion Mitigation in E-UTRAN | 130d? | 2013-09-09 A | 2014-03-06 A | 100% | 2013-09-09 | 2014-03-06 | 130d? | finish no earlier than 2014-03-06 | R2 | 1040h | 1040h | FS_SCM_LTE | 31 | LTE 36.848 | LG Electronics | youngdae.lee@lge.com | Rel-12 | 61 | Yong-Jun | FS_SCM_LTE |  |  |  | RP-140102 |
| 5442 | 1786 | Study on RAN aspects of RAN Sharing Enhancements for LTE | 136d? | 2013-12-06 A | 2014-06-13 A | 100% | 2013-12-06 | 2014-06-13 | 136d? | finish no earlier than 2014-06-13 | R3 | 1088h | 1088h | FS_RSE-RAN_LTE | 32 | LTE 36.856 | NEC | Siva.Vakeesar@emea.nec.com | Rel-12 | 62 | Juha | FS_RSE-RAN_LTE |  |  |  | RP-140746 |
| 5443 | 1787 | Study on RF and EMC requirements for active Antenna Array System (AAS) Base Station | 386d? | 2011-09-19 A | 2013-03-01 A | 100% | 2011-09-19 | 2013-03-01 | 386d? | finish no earlier than 2013-03-01 | R4; R1 | 6176h | 6176h | FS_AAS_BS_LTE_UTRA | 27 | UTRA; LTE 37.840 | Huawei | Ronnie.zhang@huawei.com | Rel-12 | 53 | Issam | FS_AAS_BS_LTE_UTRA |  |  |  | RP-130124 |
| 5444 | 1788 | Study on LTE-HRPD (High Rate Packet Data in 3GPP2) inter-RAT SON | 340d? | 2012-03-02 A | 2013-06-14 A | 100% | 2012-03-02 | 2013-06-14 | 340d? | finish no earlier than 2013-06-14 | R3 | 2712h | 2712h | FS_LTE_HRPD_SON | 28 | UTRA; LTE 37.813 | China Telecom | Wu Jinlian (wujl@gsta.com) | Rel-12 | 55 | Juha | FS_LTE_HRPD_SON | SON |  |  | RP-130585 |
| 5445 | 1789 | Study on Passive InterModulation (PIM) handling for UTRA and LTE Base Stations | 403d? | 2012-03-05 A | 2013-09-06 A | 100% | 2012-03-05 | 2013-09-06 | 403d? | finish no earlier than 2013-09-06 | R4; G1 | 6448h | 6448h | FS_BS_PIM | 28 | UTRA; LTE 37.808 | Ericsson | johan.skold@ericsson.com | Rel-12 | 55 | Issam | FS_BS_PIM |  |  |  | RP-131076 |
| 5446 | 1790 | Study on WLAN/3GPP Radio Interworking | 264d? | 2012-12-10 A | 2013-12-06 A | 100% | 2012-12-10 | 2013-12-06 | 264d? | finish no earlier than 2013-12-06 | R2 | 2104h | 2104h | FS_UTRA_LTE_WLAN_interw | 30 | UTRA; LTE 37.834 | Intel | sasha.sirotkin@intel.com | Rel-12 | 58 | Yong-Jun | FS_UTRA_LTE_WLAN_interw | WLAN |  |  | RP-131611 |
| 5447 | 1791 | Study on RAN Enhancements for UMTS/HSPA and LTE Interworking | 261d? | 2012-12-10 A | 2013-12-06 A | 100% | 2012-12-10 | 2013-12-06 | 261d? | finish no earlier than 2013-12-06 | R3 | 2088h | 2088h | FS_HSPA_LTE_interworking | 30 | UTRA; LTE 37.852 | China Unicom | Meng Zhang (zhangmeng68@chinaunicom.cn) | Rel-12 | 58 | Juha | FS_HSPA_LTE_interworking |  |  |  | RP-131612 |
| 5448 | 1792 | Study on Next-Generation SON for UTRA and LTE | 397d? | 2012-12-10 A | 2014-06-13 A | 100% | 2012-12-10 | 2014-06-13 | 397d? | finish no earlier than 2014-06-13 | R3 | 3176h | 3176h | FS_UTRA_LTE_NG_SON | 30 | UTRA; LTE 37.822 | NSN | krzysztof.kordybach@nsn.com | Rel-12 | 58 | Juha | FS_UTRA_LTE_NG_SON | SON |  |  | RP-140747 |
| 5449 | 1793 | Study on 2GHz FDD for UTRA and LTE in Region 1 (1980-2010MHz and 2170-2200MHz Bands) | 462d? | 2012-12-11 A | 2014-09-12 A | 100% | 2012-12-11 | 2014-09-12 | 462d? | finish no earlier than 2014-09-12 | R4 | 3696h | 3696h | FS_UTRA_LTE_1980_2170_REG1 | 30 | UTRA; LTE 37.846 | DISH Network | johny.kim@dish.com, mariam.sorond@dish.com | Rel-12 | 58 | Issam | FS_UTRA_LTE_1980_2170_REG1 |  |  |  | RP-141099 |
| 5450 | 1794 | Study on Base Station specification structure | 136d? | 2012-12-10 A | 2013-06-14 A | 100% | 2012-12-10 | 2013-06-14 | 136d? | finish no earlier than 2013-06-14 | R4 | 1088h | 1088h | FS_BSspec_struc | 30 | UTRA; LTE; MSR 37.810 | Ericsson | johan.skold@ericsson.com | Rel-12 | 58 | Issam | FS_BSspec_struc |  |  |  | RP-130580 |
| 5451 | 1795 | Study on RAN aspects of Machine Type and other mobile data applications Communications enhancements | 137d? | 2013-03-01 A | 2013-09-06 A | 100% | 2013-03-01 | 2013-09-06 | 137d? | finish no earlier than 2013-09-06 | R2 | 1096h | 1096h | FS_MTCe_RAN | 30 | UTRA; LTE 37.869 | ZTE | sergio.parolari@zteitaly.com | Rel-12 | 59 | Yong-Jun | FS_MTCe_RAN | MTC, M2M |  |  | RP-131081 |
| 5452 | 1796 | Study on UMTS heterogeneous networks | 331d? | 2012-06-12 A | 2013-09-06 A | 100% | 2012-06-12 | 2013-09-06 | 331d? | finish no earlier than 2013-09-06 | R1; R2; R3 | 7944h | 7944h | FS_UTRA_HetNet | 29 | UTRA 25.800 | Huawei | carmela.cozzo@huawei.com | Rel-12 | 57 | Patrick | FS_UTRA_HetNet |  |  |  | RP-131606 |
| 5453 | 1797 | Study on Scalable UMTS FDD bandwidth | 265d? | 2012-12-10 A | 2013-12-06 A | 100% | 2012-12-10 | 2013-12-06 | 265d? | finish no earlier than 2013-12-06 | R1; R4 | 4240h | 4240h | FS_UTRA_SCAL | 30 | UTRA 25.701 | China Unicom | Han Xiao (hanxiao91@chinaunicom.cn) | Rel-12 | 58 | Patrick | FS_UTRA_SCAL |  |  |  | RP-132035 |
| 5454 | 1798 | Deleted - Study on Scalable UMTS FDD bandwidth by Filtering | 136d? | 2013-12-09 A | 2014-06-13 A | 100% | 2013-12-09 | 2014-06-13 | 136d? | finish no earlier than 2014-06-13 | R1 | 1088h | 1088h | FS_UTRA_SCAL_FILT | 32 | UTRA 25.701 | China Unicom | Han Xiao (hanxiao91@chinaunicom.cn) | Rel-12 | 62 | Patrick | FS_UTRA_SCAL_FILT |  | PCG-33 | RP-64 | RP-140988 |
| 5455 | 1799 | Study on Dedicated Channel (DCH) enhancements for UMTS | 197d? | 2012-12-10 A | 2013-09-06 A | 100% | 2012-12-10 | 2013-09-06 | 197d? | finish no earlier than 2013-09-06 | R1 | 1576h | 1576h | FS_UTRA_DCHenh | 30 | UTRA 25.702 | Qualcomm | Arjun Bharadwaj (arjunb@qti.qualcomm.com) | Rel-12 | 58 | Patrick | FS_UTRA_DCHenh |  |  |  | RP-131073 |
| 5456 | 1800 | Study on Further Enhanced Uplink (EUL) enhancements | 265d? | 2012-12-10 A | 2013-12-06 A | 100% | 2012-12-10 | 2013-12-06 | 265d? | finish no earlier than 2013-12-06 | R2; R1; R3 | 6360h | 6360h | FS_EDCH_enh | 30 | UTRA 25.700 | Ericsson | alessandro.caverni@ericsson.com | Rel-12 | 58 | Yong-Jun | FS_EDCH_enh |  |  |  | RP-131608 |
| 5457 | 1801 | Study on HNB Emergency Warning Area for UTRA | 191d? | 2013-06-18 A | 2014-03-06 A | 100% | 2013-06-18 | 2014-03-06 | 191d? | finish no earlier than 2014-03-06 | R3 | 1520h | 1520h | FS_HNB_warn_area | 31 | UTRA 25.703 | Alcatel-Lucent, Ip.access | Martin.Warner@alcatel-lucent.com, Kit.kilgour@ipaccess.com | Rel-12 | 60 | Juha | FS_HNB_warn_area | HNB |  |  | RP-140129 |
| 5458 | 1802 | Study on Enhanced Broadcast of System Information | 66d? | 2013-09-09 A | 2013-12-06 A | 100% | 2013-09-09 | 2013-12-06 | 66d? | finish no earlier than 2013-12-06 | R2; R1 | 1056h | 1056h | FS_UTRA_SIBenh | 31 | UTRA 25.704 | Ericsson | martin.van.der.zee@ericsson.com | Rel-12 | 61 | Yong-Jun | FS_UTRA_SIBenh |  |  |  | RP-131610 |
| 5459 | 1803 | --- RELEASE 11 --- | 342.75d? | 2013-06-02 A | 2014-09-16 A | 100% | 2013-06-02 | 2014-09-17 | 342.75d? | finish no earlier than 2014-09-17 | SP; CP; GP; RP | 10968h | 10968h |  |  |  |  |  | Rel-11 |  | All |  |  |  |  |  |

Notes:
- 5391: Triggered by TR 22.906 SA1 Study on IMS based Peer-to-Peer Content Distribution Services UID_450047
- 5392: SP#53 completed
- 5393: SP#56 completed. TR 23.844v100 for Information and Approval
- 5394: SP#58 completed. TR 33.844 v100 for Information and Approval
- 5395: SP#62 completed. Linked to CT4 TR 23.857 Study on EPC Nodes Restoration (UID_490014)
- 5396: Phase 1: complete study of overload control related to MAP /Diameter signalling, other 3GPP Core Network signalling optimization
- 5397: SP#62 completed
- 5398: SP#56 completed
- 5399: SP#61 completed. Covers generic non-3GPP access (e.g. WLAN, WIMAX, CDMA/HRPD). Spin-off Feature SaMOG_WLAN. Linked to Rel-8 Support for non-3GPP accesses, Rel-10 SMOG, Rel-11 BBAI
- 5400: SP#61 completed. Linked to UID_350027 SAE for support for non-3GPP accesses (SAES-SA-FP_n3GPP), UID_410043 MAPIM, UID_450041 IFOM, UID_530046 SaMOG
- 5401: SP#59 completed. Linked to Rel-11 Feature UID_500032 Service Awareness and Privacy Policies (SAPP)
- 5402: Spin-off Features MAPCON, IFOM. SP#58 completed FS_MAPIM part of 23.861 (continued under FS_NBIFOM)
- 5403: SP#53 completed
- 5404: SP#43 TR 23.861v100 for Information. SP#56 Rel-9 TR 23.861v130 renamed & progressed under new Study FS_NBIFOM. SP#58 completed the FS_MAPIM part of TR 23.861 (TR continued under FS_NBIFOM).
- 5405: SP#59 stopped (at 40% completion). SP#56 revives dormant Study FS_MAPIM. TR 23.861 title changed from (Multi Access PDN connectivity and IP flow mobility) to (Network based IP flow mobility)
- 5406: SP#59 completed. Continuation of Rel-9 Feature UID_430036 IMS Media Plane Security (MEDIASEC). Study solutions and extensions to features and functionality described in TR 33.828 and TS 33.328
- 5407: SP#65 stopped. Linked to Rel-12 Service and Media Reachability for Users over Restrictive Firewalls (SMURFs) UID_530043
- 5408: SP#65 completed. TR 33.831v100 for 1-step Approval. Linked to Rel-11 SPUCI TR 33.838
- 5409: SP#64 completed. Spin-off Rel-13 Feature SCAS. Study methodologies for specifying product security assurance and hardening requirements on 3GPP network elements (with associated test cases when feasible)
- 5410: SP#65 completed. TR 26.938v200 for Approval. SP#60 TR 26.938v100 for Information. Linked to Feature UID_470034 HTTP-based Streaming and Download Services
- 5411: SP#65 completed. TR 26.907v200 for Approval. SP#64 TR 26.907v100 for Information.
- 5412: SP#58 completed
- 5413: SP#64 completed
- 5414: SP#61 completed. Linked to Network Sharing UID_31018, SA1 22.951 (Service aspects and requirements for network sharing), SA2 23.251 (Network Sharing¦Architecture)
- 5415: SP#65 completed. TR 32.836v200 for Approval. SP#63 split of Rel-12 SP-130045 WID (Enhanced NM Centralized Coverage and Capacity Optimization) into a Rel-12 Study (SP-140028) and a Rel-13 Normative WID (SP-140060)
- 5416: SP#65 revised WID SP-130042=>SP-140536 (split into Rel-12 Study & Rel-13 normative WI). Changed Title from "TR on WLAN impacts to Type-2 management interface to the 3GPP Network Manager". TR 32.841v200 for Approval. Completed¦14/09/15: WID:SP-140536->
- 5417: SP#61 completed
- 5418: CP#64 completed
- 5419: CP#65 completed. TR 29.809 v200 for Approval. Triggered by SA2 Rel-12 TR 23.843 Study on Core Network Overload solutions (FS_CNO) UID_490036. Coordinate with CT3, SA5
- 5420: CP#64 completed. Investigate introducing an XML-based protocol (e.g. SOAP, Restful HTTP, etc.) between AF and PCRF for non-IMS applications
- 5421: CP#65 completion 09/14=>12/14. CP#64 TR 29.949v100 for Information.Dec.14:95->100
- 5422: CP#65 completion 09/14=>12/14. Gathering of all ISIM-related conformance requirements and the assessment of CT6 coverage¦June2015: Compl:30%->100
- 5423: CP#65 TR 29.854v200 for Approval. Completion 09/14=>12/14. Dec.14: 80->85%. Mar.15: 100%
- 5424: GP#56 completed. GP#44 approved WID
- 5425: GP#62 completed. TR 43.801v100 for 1-step Approval. GP#50 approved WID. Triggered by Rel-8 TR 45.914 Study Multi-User-Reusing One Timeslot (MUROS) UID_50590 and Rel-9 VAMOS UID_420002
- 5426: GP#63 completed. TR~43.802v200 for Approval. GP#50 approved WID (mobile coucou). Triggered by RAN#51 (Mar 2011) WID in RP-110454 (LTE RAN Enhancements for Diverse Data Applications) UID_510031
- 5427: RP#61 completed. Linked to Rel-10 WI on Inclusion of RF Pattern Matching Technologies as a positioning method in the UTRAN (LCS_UMTS_RFPMT) UID_460005
- 5428: RP#60 completed
- 5429: RP#64 stopped at 80% completion
- 5430: RP#58 completed. TR 36.932 v100 for Information and Approval
- 5431: RP#62 completed. RP#61 TR 36.872v100 for 1-step approval. Triggered by Rel-12 TR 36.932 Study on Scenarios and Requirements of LTE Small Cell Enhancements for E-UTRA and E-UTRAN UID_570023
- 5432: RP#62 completed. Triggered by Rel-12 TR 36.932 Study on Scenarios and Requirements of LTE Small Cell Enhancements for E-UTRA and E-UTRAN UID_570023
- 5433: RP#63 completed. TR 36.843 for 1-step approval (90% complete). Started normative work. Linked to Rel-12 TR 22.803 Study on Proximity-based Services (FS_ProSe) and Feature ProSe
- 5434: RP#65 completed. Updated WID RP-130811=>RP-141237. TR 36.873v210 for Approval. Enhance performance with 3D-beamforming or with FD-MIMO. Study new channel modelling in both vertical and horizontal dimensions awa user locations in the network
- 5435: RP#64 completed. Identify potential solutions for energy saving in E-UTRAN non-overlapping scenario. Evaluate possible enhancements in overlapping scenario, so that a subset can be used for further investigation/standardization
- 5436: CD:Thu 11/12/14->Mon 15/12/14¦Compl:80%->100%¦Stat Rep: RP-141453->RP-141815
- 5437: RP#62 completed. Updated WID RP-130393=>RP-131840
- 5438: RP#63 completed. TR 36.866 (90% complete) for Approval. Started normative work
- 5439: RP#62 completed. Extension of Rel-11 CoMP Operation for LTE Downlink UID_530332)
- 5440: RP#63 completed. Evaluate ability of LTE to meet public safety requirements agreed in SA for GC (GC is a key functionality of Land Mobile Radio/Private Mobile Radio and public safety systems)
- 5441: RP#63 completed
- 5442: RP#64 completed. TR 36.856v100 for 1-step approval. Triggered by SA1 Re-12 TR 22.852 Study on RAN Sharing Enhancements (FS_RSE) and Rel-13 Feature RSE (TS 22.101 Stage 1)
- 5443: RP#59 completed
- 5444: RP#60 completed
- 5445: RP#61 completed (Conclusion: no spin-off WI). Linked to Rel-10 WI on Multi-standard radio Base Station RF requirements for non-contiguous spectrum deployments (MSR_NC) UID_480025
- 5446: RP#62 completed. Evaluate LTE-WLAN/UTRA-WLAN i/w procedures while improving (non-)seamless mobility. Deployed WLAN often under-utilized¦User experience suboptimal when UE connects to overloaded WLAN.
- 5447: RP#62 completed. TR 37.852v100 for Information & Approval
- 5448: RP#64 completed. The study of SON features for small cell functionality covered by the Rel-12 small cell enhancement SIs (e.g. dual connectivity) is not in the scope of this study item
- 5449: RP#65 completed. Within EU these bands can be used for terrestrial mobile as a complement to mobile satellite services. Study adding an FDD band into UTRA/E-UTRA in applicable countries of Region 1
- 5450: RP#60 completed (1-step approval). Study new BS spec structure to avoid duplicate work for new RF features (in case of identical features among different RATs)¦avoid future discussions on how to implement new featurES in CP-150single-RAT/multi-RAT specs
- 5451: RP#61 completed
- 5452: RP#62 completed
- 5453: RP#62 completed. TR 25.701v200 for Approval
- 5454: RP#64 stopped at 85% completion. Follow-up of Rel-12 Study on scalable UMTS FDD bandwidth (FS_UTRA_SCAL). The result is captured in the same TR 25.701
- 5455: RP#61 completed
- 5456: RP#62 completed. TR 25.700v100 for Approval. Identify potential solutions to increase the uplink capacity, coverage and end-user performance (e.g. latency, achievable rates, etc.)
- 5457: RP#63 completed. TR 25.703 v100 for 1-step approval
- 5458: RP#62 completed. TR 25.704v100 for Information & Approval. Study need to add capacity to present SI Broadcast mechanism unchanged since R99
- 5459: -

| ID | WBS | Task | Duration | Start | Finish | Complete | Baseline start | Baseline finish | Baseline duration | Constraint | Resources | Work | Actual work | Acronym | PCG approved | WI rapporteur name | WI rapporteur e-mail | Release | TSG approved | MCC resp | Acronym_3GU_Export | Impacted TSs and TRs | Special Focus Doc | PCG stopped | TSG stopped |
| --- | --- | --- | --- | --- | --- | --- | --- | --- | --- | --- | --- | --- | --- | --- | --- | --- | --- | --- | --- | --- | --- | --- | --- | --- | --- |
| 5460 | 1804 | **Advanced IP Interconnection of Services** | 650d? | 2010-03-25 A | 2012-09-12 A | 100% | 2010-03-25 | 2012-09-12 | 650d? |  | S1; S2; C1; C3 | 34381.9h | 34381.9h | IPXS | 24 | Telefónica | chris.friel@O2.com | Rel-11 | 47 | Alain | IPXS |  |  |  |  |
| 5461 | 1804.1 | Stage 1 for Advanced IP Interconnection of Services | 392d | 2010-03-25 A | 2011-09-21 A | 100% | 2010-03-25 | 2011-09-21 | 392d | finish no earlier than 2011-09-21 | S1 | 3120h | 3120h | IPXS | 24 | Telefónica | chris.friel@O2.com | Rel-11 | 47 | Alain |  | 22.101; 22.228 |  |  |  |
| 5462 | 1804.2 | Stage 2 for Advanced IP Interconnection of Services | 263d? | 2010-12-16 A | 2011-12-14 A | 100% | 2010-12-16 | 2011-12-14 | 263d? | finish no earlier than 2012-03-21 | S2 | 2085.91h | 2085.91h | IPXS | 26 | Ericsson | fredrik.lindholm@ericsson.com | Rel-11 | 50 | Maurice |  | 23.228 |  |  |  |
| 5463 | 1804.3 | **Stage 3 for Advanced IP Interconnection of Services** | 265d? | 2011-09-13 A | 2012-09-12 A | 100% | 2011-09-13 | 2012-09-12 | 265d? |  | C1; C3 | 8376h | 8376h | IPXS | 27 | Ericsson | christer.holmberg@ericsson.com | Rel-11 | 53 | Frederic |  | Stage 3 |  |  |  |
| 5464 | 1804.3.1 | CT1 part of Stage 3 for Advanced IP Interconnection of Services | 262d? | 2011-09-16 A | 2012-09-12 A | 100% | 2011-09-16 | 2012-09-12 | 262d? | finish no earlier than 2012-12-07 | C1 | 2048h | 2048h | IPXS | 27 | Ericsson | christer.holmberg@ericsson.com | Rel-11 | 53 | Frederic |  | 24.229 |  |  |  |
| 5465 | 1804.3.2 | CT3 part of Stage 3 for Advanced IP Interconnection of Services | 262d? | 2011-09-13 A | 2012-09-07 A | 100% | 2011-09-13 | 2012-09-07 | 262d? | finish no earlier than 2012-09-07 | C3 | 2088h | 2088h | IPXS | 27 | Ericsson | christer.holmberg@ericsson.com | Rel-11 | 53 | Adrian |  | 29.165 |  |  |  |
| 5466 | 1805 | **System Improvements to Machine-Type Communications** | 1119d? | 2009-12-10 A | 2014-03-06 A | 100% | 2009-12-10 | 2014-03-06 | 1119d? |  | S1; S2; S5; C1; C3; C4; C6; R2; R3; R5 | 198763h | 198763h | SIMTC | 25 | KPN | toon.norp@tno.nl | Rel-11 | 48 | Alain | SIMTC |  | MTC, M2M |  |  |
| 5467 | 1805.1 | Stage 1 for SIMTC | 337d? | 2010-06-10 A | 2011-09-21 A | 100% | 2010-06-10 | 2011-09-21 | 337d? |  | S1 | 2683.46h | 2683.46h | SIMTC | 25 | KPN | toon.norp@tno.nl | Rel-11 | 48 | Alain |  | 22.368; 21.905 (MTC definitions) | MTC, M2M |  |  |
| 5468 | 1805.2 | TR on Stage 2 for SIMTC | 593d? | 2010-06-10 A | 2012-09-12 A | 100% | 2010-06-10 | 2012-09-12 | 593d? | finish no earlier than 2012-09-12 | S2 | 4736h | 4736h | SIMTC | 25 | Intel | puneet.jain@intel.com | Rel-11 | 48 | Maurice |  | New 23.888 | MTC, M2M |  |  |
| 5469 | 1805.3 | **BB1: Stage 2 Reachability Aspects of SIMTC** | 274d? | 2011-06-09 A | 2012-06-20 A | 100% | 2011-06-09 | 2012-06-20 | 274d? |  | S2 | 10773.1h | 10773.1h | SIMTC-Reach | 27 | Intel | puneet.jain@intel.com | Rel-11 | 52 | Maurice | SIMTC-Reach | 23.221; New 23.368 | MTC, M2M |  |  |
| 5470 | 1805.3.1 | Deleted - MTC Feature Control (described in TS 22.368, clause 7.1.1 and 23.888, clause 5.7) | 137d? | 2011-06-10 A | 2011-12-14 A | 100% | 2011-06-10 | 2011-12-14 | 137d? | finish no earlier than 2011-11-09 | S2 | 1088h | 1088h | SIMTC-Reach | 27 | Intel | puneet.jain@intel.com | Rel-11 | 52 | Maurice |  |  | MTC, M2M | PCG-28 | SP-54 |
| 5471 | 1805.3.2 | On-line device trigger | 273d? | 2011-06-09 A | 2012-06-20 A | 100% | 2011-06-09 | 2012-06-20 | 273d? | finish no earlier than 2012-06-20 | S2 | 2170.29h | 2170.29h | SIMTC-Reach | 27 | Intel | puneet.jain@intel.com | Rel-11 | 52 | Maurice |  | New 23.682 | MTC, M2M |  |  |
| 5472 | 1805.3.3 | MTC Addressing | 138d? | 2011-06-09 A | 2011-12-14 A | 100% | 2011-06-09 | 2011-12-14 | 138d? | finish no earlier than 2012-03-21 | S2 | 1097.24h | 1097.24h | SIMTC-Reach | 27 | Intel | puneet.jain@intel.com | Rel-11 | 52 | Maurice |  | 23.221; New 23.682 | MTC, M2M |  |  |
| 5473 | 1805.3.4 | Identifiers – especially removal of MSISDN dependencies in the architecture | 273d? | 2011-06-09 A | 2012-06-20 A | 100% | 2011-06-09 | 2012-06-20 | 273d? | finish no earlier than 2012-06-20 | S2 | 2169.53h | 2169.53h | SIMTC-Reach | 27 | Intel | puneet.jain@intel.com | Rel-11 | 52 | Maurice |  | New 23.682 | MTC, M2M |  |  |
| 5474 | 1805.3.5 | MSISDN-less / PS-Only | 196d? | 2011-06-13 A | 2012-03-07 A | 100% | 2011-06-13 | 2012-03-07 | 196d? | finish no earlier than 2012-03-07 | S2 | 1568h | 1568h | SIMTC-Reach | 27 | Intel | puneet.jain@intel.com | Rel-11 | 52 | Maurice |  | 23.060; 23.272; New 23.682 | MTC, M2M |  |  |
| 5475 | 1805.3.6 | MTC related interfaces and functional entities to support above features (MTCsp, etc.) | 61d? | 2011-12-14 A | 2012-03-07 A | 100% | 2011-12-14 | 2012-03-07 | 61d? | finish no earlier than 2012-03-07 | S2 | 488h | 488h | SIMTC-Reach | 28 | Intel | puneet.jain@intel.com | Rel-11 | 54 | Maurice |  | New 23.682 | MTC, M2M |  |  |
| 5476 | 1805.4 | **BB1: Stage 3 (CS+PS) Reachability Aspects of SIMTC** | 325d? | 2011-09-19 A | 2012-12-07 A | 100% | 2011-09-19 | 2012-12-07 | 325d? |  | C1; C3; C4; C6 | 19112h | 19112h | SIMTC-ReachCSPS | 27 | Ericsson | mikael.wass@ericsson.com | Rel-11 | 53 | Frederic |  | Stage 3 | MTC, M2M |  |  |
| 5477 | 1805.4.1 | CT1 part of Stage 3 BB1: Reachability Aspects of SIMTC | 257d? | 2011-09-19 A | 2012-09-07 A | 100% | 2011-09-19 | 2012-09-07 | 257d? | finish no earlier than 2012-09-07 | C1 | 2048h | 2048h | SIMTC-ReachCSPS | 27 | Ericsson | mikael.wass@ericsson.com | Rel-11 | 53 | Frederic |  | 23.040; 24.008; 24.301; 24.341; 24.368 | MTC, M2M |  |  |
| 5478 | 1805.4.2 | CT3 part of Stage 3 BB1: Reachability Aspects of SIMTC | 257d? | 2011-09-19 A | 2012-09-07 A | 100% | 2011-09-19 | 2012-09-07 | 257d? | finish no earlier than 2012-09-07 | C3 | 2048h | 2048h | SIMTC-ReachCSPS | 27 | Ericsson | mikael.wass@ericsson.com | Rel-11 | 53 | Adrian |  | 29.061; New 29.368 | MTC, M2M |  |  |
| 5479 | 1805.4.3 | CT4 part of Stage 3 BB1: Reachability Aspects of SIMTC | 324d? | 2011-09-19 A | 2012-12-07 A | 100% | 2011-09-19 | 2012-12-07 | 324d? | finish no earlier than 2012-12-07 | C4 | 2568h | 2568h | SIMTC-ReachCSPS | 27 | Ericsson | mikael.wass@ericsson.com | Rel-11 | 53 | Kimmo |  | 23.003; 23.008; 29.002; 29.060; 29.230; New (29.336; 29.337) | MTC, M2M |  |  |
| 5480 | 1805.4.4 | CT6 part of Stage 3 BB1: Reachability Aspects of SIMTC | 257d? | 2011-09-19 A | 2012-09-07 A | 100% | 2011-09-19 | 2012-09-07 | 257d? | finish no earlier than 2012-09-07 | C6 | 2048h | 2048h | SIMTC-ReachCSPS | 27 | ST Ericsson | Andrzej Winiarski | Rel-11 | 53 | Xavier |  | 31.102 | MTC, M2M |  |  |
| 5481 | 1805.5 | **Stage 2/3 for CS aspects for SIMTC** | 259d? | 2011-09-16 A | 2012-09-07 A | 100% | 2011-09-16 | 2012-09-07 | 259d? |  | C4; C1; C6 | 16544h | 16544h | SIMTC-CS | 27 | Ericsson | mikael.wass@ericsson.com | Rel-11 | 53 | Kimmo | SIMTC-CS | Stage 2/3 | MTC, M2M |  |  |
| 5482 | 1805.5.1 | Deleted - Stage 2 CS aspects for SIMTC | 258d? | 2011-09-16 A | 2012-09-06 A | 100% | 2011-09-16 | 2012-09-06 | 258d? | finish no earlier than 2012-09-07 | C4 | 2056h | 2056h | SIMTC-CS | 27 | Ericsson | mikael.wass@ericsson.com | Rel-11 | 53 | Kimmo |  | 23.012 | MTC, M2M | PCG-29 | CP-57 |
| 5483 | 1805.5.2 | **Stage 3 CS aspects for SIMTC** | 259d? | 2011-09-16 A | 2012-09-07 A | 100% | 2011-09-16 | 2012-09-07 | 259d? |  | C1; C6 | 8272h | 8272h | SIMTC-CS | 27 | Ericsson | mikael.wass@ericsson.com | Rel-11 | 53 | Frederic |  | Stage 3 | MTC, M2M |  |  |
| 5484 | 1805.5.2.1 | CT1 part of Stage 3 CS aspects for SIMTC | 259d? | 2011-09-16 A | 2012-09-07 A | 100% | 2011-09-16 | 2012-09-07 | 259d? | start no earlier than 2011-09-16 | C1 | 2064h | 2064h | SIMTC-CS | 27 | Ericsson | mikael.wass@ericsson.com | Rel-11 | 53 | Frederic |  | 24.008; 24.301 | MTC, M2M |  |  |
| 5485 | 1805.5.2.2 | Deleted - CT6 part of Stage 3 CS aspects for SIMTC | 259d? | 2011-09-16 A | 2012-09-07 A | 100% | 2011-09-16 | 2012-09-07 | 259d? | start no earlier than 2011-09-16 | C6 | 2064h | 2064h | SIMTC-CS | 27 | Ericsson | mikael.wass@ericsson.com | Rel-11 | 53 | Xavier |  | 31.102 | MTC, M2M | PCG-29 | CP-57 |

Notes:
- 5460: CP#58 completed. Triggered by Rel-10 TR 22.893 UID_380083 Study on advanced requirements for IP interconnect (FS_IPXS)
- 5461: SP#53 completed
- 5462: SP#54 completed
- 5463: CP#58 completed
- 5464: CP#58 completed
- 5465: CP#57 completed
- 5466: SP#58 completed. Updated WID SP-110877=>SP-120848. Enhancements to Rel-10 Feature UID_410031 (NIMTC) based on Rel-11 Study on enhancements to MTC
- 5467: SP#53 completed. SP#57 added MTC definitions in 21.905
- 5468: SP#57 completed. TR 23.888v200 for Approval. Was Rel-10 UID_450028 (TR on Stage 2 for NIMTC)
- 5469: SP#56 completed. SP#58 updated WID SP-110877=>S3-121111 (SA3 normative work on Security aspects of SIMTC incorporated in SA2 TS 23.682)
- 5470: SP#54 work stopped
- 5471: SP#56 completed
- 5472: SP#54 completed
- 5473: SP#56 completed
- 5474: SP#55 completed
- 5475: SP#55 completed
- 5476: 22/01: acronym modified
- 5477: 22/01: acronym modified
- 5478: 22/01: acronym modified
- 5479: 22/01: acronym modified
- 5480: 22/01: acronym modified
- 5481: CP#57 completed. Updated WID CP-120418=>CP-120617
- 5482: CP#57 stopped
- 5483: CP#57 completed
- 5484: CP#57 completed
- 5485: CP#57 stopped

| ID | WBS | Task | Duration | Start | Finish | Complete | Baseline start | Baseline finish | Baseline duration | Constraint | Resources | Work | Actual work | Acronym | PCG approved | WI rapporteur name | WI rapporteur e-mail | Release | TSG approved | MCC resp | Special Focus Doc | Acronym_3GU_Export | Status Report | PCG stopped | TSG stopped |
| --- | --- | --- | --- | --- | --- | --- | --- | --- | --- | --- | --- | --- | --- | --- | --- | --- | --- | --- | --- | --- | --- | --- | --- | --- | --- |
| 5486 | 1805.6 | **Stage 2/3 for SMS in MME architecture option and related PS-only service subscription** | 129d? | 2012-06-15 A | 2012-12-07 A | 100% | 2012-06-15 | 2012-12-07 | 129d? |  | C1; C4 | 3560h | 3560h | SIMTC-PS_Only | 29 | Ericsson | mikael.wass@ericsson.com | Rel-11 | 56 | Frederic | MTC, M2M | SIMTC-PS_Only |  |  |  |
| 5487 | 1805.6.1 | CT1 part of Stage 2/3 for SMS in MME architecture option and related PS-only service subscription | 62d? | 2012-06-15 A | 2012-09-07 A | 100% | 2012-06-15 | 2012-09-07 | 62d? | finish no earlier than 2012-09-07 | C1 | 488h | 488h | SIMTC-PS_Only | 29 | Ericsson | mikael.wass@ericsson.com | Rel-11 | 56 | Frederic | MTC, M2M |  |  |  |  |
| 5488 | 1805.6.2 | CT4 part of Stage 2/3 for SMS in MME architecture option and related PS-only service subscription | 129d? | 2012-06-15 A | 2012-12-07 A | 100% | 2012-06-15 | 2012-12-07 | 129d? | finish no earlier than 2012-12-07 | C4 | 1008h | 1008h | SIMTC-PS_Only | 29 | Ericsson | mikael.wass@ericsson.com | Rel-11 | 56 | Kimmo | MTC, M2M |  |  |  |  |
| 5489 | 1805.7 | **RAN overload control for Machine-Type Communications** | 259d? | 2011-09-16 A | 2012-09-07 A | 100% | 2011-09-16 | 2012-09-07 | 259d? |  | R2; R3; C1; C6 | 20178.3h | 20178.3h | SIMTC-RAN_OC | 27 | Huawei | Jeff Gao (gaoyongqiang@huawei.com) | Rel-11 | 53 | Yong-Jun | MTC, M2M | SIMTC-RAN_OC |  |  |  |
| 5490 | 1805.7.1 | Core part: RAN overload control for Machine-Type Communications | 258d? | 2011-09-19 A | 2012-09-07 A | 100% | 2011-09-19 | 2012-09-07 | 258d? | finish no earlier than 2012-09-07 | R2; R3 | 4128h | 4128h | SIMTC-RAN_OC-Core | 27 | Huawei | Jeff Gao (gaoyongqiang@huawei.com) | Rel-11 | 53 | Yong-Jun | MTC, M2M | SIMTC-RAN_OC-Core |  |  |  |
| 5491 | 1805.7.2 | **Stage 3 (CS+PS) Extended Access Barring for UTRAN and E-UTRAN** | 259d? | 2011-09-16 A | 2012-09-07 A | 100% | 2011-09-16 | 2012-09-07 | 259d? |  | C1; C6 | 7762.29h | 7762.29h | SIMTC-RAN_OC | 27 | Ericsson | mikael.wass@ericsson.com | Rel-11 | 53 | Frederic | MTC, M2M |  |  |  |  |
| 5492 | 1805.7.2.1 | CT1 part of Stage 3 Extended Access Barring for UTRAN and E-UTRAN | 198d? | 2011-09-16 A | 2012-06-15 A | 100% | 2011-09-16 | 2012-06-15 | 198d? | finish no earlier than 2012-09-14 | C1 | 1570.29h | 1570.29h | SIMTC-RAN_OC | 27 | Ericsson | mikael.wass@ericsson.com | Rel-11 | 53 | Frederic | MTC, M2M |  |  |  |  |
| 5493 | 1805.7.2.2 | CT6 part of Stage 3 Extended Access Barring for UTRAN and E-UTRAN | 257d? | 2011-09-20 A | 2012-09-07 A | 100% | 2011-09-20 | 2012-09-07 | 257d? | finish no earlier than 2012-09-07 | C6 | 2048h | 2048h | SIMTC-RAN_OC | 27 | ST Ericsson | Andrzej Winiarski | Rel-11 | 53 | Xavier | MTC, M2M |  |  |  |  |
| 5494 | 1805.8 | Test part: System Improvements for Machine-Type Communications | 130d? | 2013-09-09 A | 2014-03-06 A | 100% | 2013-09-09 | 2014-03-06 | 130d? | finish no earlier than 2014-03-06 | R5 | 1040h | 1040h | SIMTC-UEConTest | 31 | Ericsson | calle.hagenfeldt@ericsson.com | Rel-11 | 61 | Ingbert | MTC, M2M | SIMTC-UEConTest | RP-140075 |  |  |
| 5495 | 1805.9 | BB5: Charging of SIMTC (Stage 2/3) | 269d? | 2011-12-07 A | 2012-12-12 A | 100% | 2011-12-07 | 2012-12-12 | 269d? | finish no earlier than 2012-12-12 | S5 | 2144h | 2144h | SIMTC-CH | 28 | Ericsson | patrik.teppo@ericsson.com | Rel-11 | 54 | Mirko | MTC, M2M | SIMTC-CH |  |  |  |
| 5496 | 1805.10 | **Deleted - BB2: Stage 2 Signalling Optimizations of SIMTC** | 137d? | 2011-06-10 A | 2011-12-14 A | 100% | 2011-06-10 | 2011-12-14 | 137d? |  | S2 | 5240h | 5240h | SIMTC-Sig | 27 | Intel | puneet.jain@intel.com | Rel-11 | 52 | Maurice | MTC, M2M | SIMTC-Sig |  | PCG-28 | SP-55 |
| 5497 | 1805.10.1 | Deleted - Effectively maintain connectivity for a large number of MTC Devices (TS 22.368, 7.1.1) | 137d? | 2011-06-10 A | 2011-12-14 A | 100% | 2011-06-10 | 2011-12-14 | 137d? | finish no earlier than 2011-12-07 | S2 | 1088h | 1088h | SIMTC-Sig | 27 | Intel | puneet.jain@intel.com | Rel-11 | 52 | Maurice | MTC, M2M |  |  | PCG-28 | SP-55 |
| 5498 | 1805.10.2 | Deleted - Small Data Transmissions (TS 22.368, 7.2.5) | 137d? | 2011-06-10 A | 2011-12-14 A | 100% | 2011-06-10 | 2011-12-14 | 137d? | finish no earlier than 2011-12-07 | S2 | 1088h | 1088h | SIMTC-Sig | 27 | Intel | puneet.jain@intel.com | Rel-11 | 52 | Maurice | MTC, M2M |  |  | PCG-28 | SP-55 |
| 5499 | 1805.10.3 | **Deleted - Stage 3 (CS+PS) Signalling Optimizations of SIMTC** | 62d? | 2011-09-16 A | 2011-12-09 A | 100% | 2011-09-16 | 2011-12-09 | 62d? |  | C1; C6 | 1968h | 1968h | SIMTC-Sig | 27 | Ericsson | mikael.wass@ericsson.com | Rel-11 | 53 | Frederic | MTC, M2M |  |  | PCG-28 | CP-55 |
| 5500 | 1805.10.3.1 | Deleted - CT1 part of Stage 3 Signalling Optimizations of SIMTC | 62d? | 2011-09-16 A | 2011-12-09 A | 100% | 2011-09-16 | 2011-12-09 | 62d? | finish no earlier than 2011-12-02 | C1 | 488h | 488h | SIMTC-Sig | 27 | Ericsson | mikael.wass@ericsson.com | Rel-11 | 53 | Frederic | MTC, M2M |  |  | PCG-28 | CP-55 |
| 5501 | 1805.10.3.2 | Deleted - CT6 part of Stage 3 Signalling Optimizations of SIMTC | 62d? | 2011-09-16 A | 2011-12-09 A | 100% | 2011-09-16 | 2011-12-09 | 62d? | finish no earlier than 2011-12-02 | C6 | 488h | 488h | SIMTC-Sig | 27 | ST Ericsson | Andrzej Winiarski | Rel-11 | 53 | Xavier | MTC, M2M |  |  | PCG-28 | CP-55 |
| 5502 | 1805.11 | **Deleted - BB3: Stage 2 CN-based requirements and Power Considerations of SIMTC** | 139d? | 2011-06-08 A | 2011-12-14 A | 100% | 2011-06-08 | 2011-12-14 | 139d? |  | S2 | 6360h | 6360h | SIMTC-CN_Pow | 27 | Intel | puneet.jain@intel.com | Rel-11 | 52 | Maurice | MTC, M2M | SIMTC-CN_Pow |  | PCG-28 | SP-55 |
| 5503 | 1805.11.1 | Deleted - Charging Requirements (TS 22.368, 7.1.5) | 137d? | 2011-06-10 A | 2011-12-14 A | 100% | 2011-06-10 | 2011-12-14 | 137d? | finish no earlier than 2012-03-21 | S2 | 1088h | 1088h | SIMTC-CN_Pow | 27 | Intel | puneet.jain@intel.com | Rel-11 | 52 | Maurice | MTC, M2M |  |  | PCG-28 | SP-55 |
| 5504 | 1805.11.2 | Deleted - Lower Power Consumption (TS 22.368, 7.1.1) | 137d? | 2011-06-10 A | 2011-12-14 A | 100% | 2011-06-10 | 2011-12-14 | 137d? | finish no earlier than 2011-12-07 | S2 | 1088h | 1088h | SIMTC-CN_Pow | 27 | Intel | puneet.jain@intel.com | Rel-11 | 52 | Maurice | MTC, M2M |  |  | PCG-28 | SP-55 |
| 5505 | 1805.11.3 | Deleted - MTC Monitoring (TS 22.368, 7.2.8) | 139d? | 2011-06-08 A | 2011-12-14 A | 100% | 2011-06-08 | 2011-12-14 | 139d? | finish no earlier than 2011-12-07 | S2 | 1104h | 1104h | SIMTC-CN_Pow | 27 | Intel | puneet.jain@intel.com | Rel-11 | 52 | Maurice | MTC, M2M |  |  | PCG-28 | SP-55 |
| 5506 | 1805.11.4 | **Deleted - Stage 3 (CS+PS) CN-based requirements and Power Considerations of SIMTC** | 62d? | 2011-09-16 A | 2011-12-09 A | 100% | 2011-09-16 | 2011-12-09 | 62d? |  | C1; C6 | 1968h | 1968h | SIMTC-CN_Pow | 27 | Ericsson | mikael.wass@ericsson.com | Rel-11 | 53 | Frederic | MTC, M2M |  |  | PCG-28 | CP-55 |
| 5507 | 1805.11.4.1 | Deleted - CT1 part of Stage 3 CN-based requirements and Power Considerations of SIMTC | 62d? | 2011-09-16 A | 2011-12-09 A | 100% | 2011-09-16 | 2011-12-09 | 62d? | finish no earlier than 2011-12-02 | C1 | 488h | 488h | SIMTC-CN_Pow | 27 | Ericsson | mikael.wass@ericsson.com | Rel-11 | 53 | Frederic | MTC, M2M |  |  | PCG-28 | CP-55 |
| 5508 | 1805.11.4.2 | Deleted - CT6 part of Stage 3 CN-based requirements and Power Considerations of SIMTC | 62d? | 2011-09-16 A | 2011-12-09 A | 100% | 2011-09-16 | 2011-12-09 | 62d? | finish no earlier than 2011-12-02 | C6 | 488h | 488h | SIMTC-CN_Pow | 27 | ST Ericsson | Andrzej Winiarski | Rel-11 | 53 | Xavier | MTC, M2M |  |  | PCG-28 | CP-55 |
| 5509 | 1805.12 | Deleted - TR on Security aspects of Machine-Type Communications | 662d? | 2009-12-10 A | 2012-06-20 A | 100% | 2009-12-10 | 2012-06-20 | 662d? | finish no earlier than 2012-06-20 | S3 | 5288h | 5288h |  | 25 | Samsung | Rajavelsamy R (rajvel@samsung.com) | Rel-11 | 49 | Mirko | MTC, M2M |  |  | PCG-29 | SP-56 |

Notes:
- 5486: CP#58 completed / Impacted TSs and TRs: Stage 2/3
- 5487: CP#57 completed / Impacted TSs and TRs: 23.040; 24.008; 24.011; 24.301; 29.018; 29.118
- 5488: CP#58 completed. TS 29.338 v200 for Approval / Impacted TSs and TRs: 23.003; 23.008; 23.012; 29.002; 29.272; 29.305; New 29.338
- 5489: Stage 2,3. TSG#57 completed / Impacted TSs and TRs: UTRA; LTE
- 5490: RP#57 completed / Impacted TSs and TRs: 25.304; 25.331; 25.413; 36.304; 36.331; 36.413
- 5491: CP#57 completed. Updated WID CP-120418=>CP-120617 / Impacted TSs and TRs: Stage 3
- 5492: CP#56 completed / Impacted TSs and TRs: 23.122; 24.008; 24.301
- 5493: CP#57 completed / Impacted TSs and TRs: 31.102
- 5494: RP#63 completed. Updated WID RP-131341=>RP-140077 (added affected TS 36.508). Testing for core part: SIMTC-Reach, SIMTC-CS, SIMTC-PS_Only, SIMTC-RAN_OC / Impacted TSs and TRs: 34.123-1; 34.123-2; 34.123-3; 36.508; 36.523-1; 36.523-2; 36.523-3
- 5495: SP#58 completed / Impacted TSs and TRs: 32.240; 32.251; 32.298; 32.299
- 5496: SP#54 work stopped. SP#58 updated WID SP-110877=>SP-120848 / Impacted TSs and TRs: TBD
- 5497: SP#54 work stopped / Impacted TSs and TRs: TBD
- 5498: SP#54 work stopped / Impacted TSs and TRs: TBD
- 5499: CP#54 work stopped / Impacted TSs and TRs: Stage 3
- 5500: - / Impacted TSs and TRs: 23.122; 24.008; 24.301; 24.368
- 5501: - / Impacted TSs and TRs: 31.102
- 5502: SP#54 work stopped / Impacted TSs and TRs: TBD
- 5503: SP#54 work stopped / Impacted TSs and TRs: TBD
- 5504: SP#54 work stopped / Impacted TSs and TRs: TBD
- 5505: SP#54 work stopped / Impacted TSs and TRs: TBD
- 5506: CP#54 work stopped / Impacted TSs and TRs: Stage 3
- 5507: - / Impacted TSs and TRs: 23.122; 24.008; 24.301; 24.368
- 5508: - / Impacted TSs and TRs: 31.101; 31.102
- 5509: Was Rel-10 UID_460023 (Security for NIMTC). SP#56 stopped (activity transferred to Rel-12 Feature MTCe under UID_560722). / Impacted TSs and TRs: New 33.868

| ID | WBS | Task | Type | Duration | Start | Finish | Complete | Baseline start | Baseline finish | Baseline duration | Constraint | Resources | Work | Actual work | Acronym | PCG approved | Impacted TSs and TRs | WI rapporteur name | Release | TSG approved | MCC resp | PCG stopped | TSG stopped | Special Focus Doc | Acronym_3GU_Export |
| --- | --- | --- | --- | --- | --- | --- | --- | --- | --- | --- | --- | --- | --- | --- | --- | --- | --- | --- | --- | --- | --- | --- | --- | --- | --- |
| 5510 | 1805.13 | **Deleted - BB4: Secure Connection and Privacy of SIMTC** |  | 336d? | 2011-06-08 A | 2012-09-12 A | 100% | 2011-06-08 | 2012-09-12 | 336d? |  | S3 | 7424h | 7424h | SIMTC-Sec | 27 | TBD | Samsung | Rel-11 | 52 | Mirko | PCG-29 | CP-57 | MTC, M2M | SIMTC-Sec |
| 5511 | 1805.13.1 | Deleted - Secure Connection MTC Feature (TS 22.368, 7.2.10) |  | 333d? | 2011-06-08 A | 2012-09-12 A | 100% | 2011-06-08 | 2012-09-12 | 333d? | finish no earlier than 2012-09-12 | S3 | 2656h | 2656h | SIMTC-Sec | 27 | TBD | Samsung | Rel-11 | 52 | Mirko | PCG-29 | CP-57 | MTC, M2M |  |
| 5512 | 1805.13.2 | Deleted - MTC Location Privacy |  | 261d? | 2011-09-19 A | 2012-09-12 A | 100% | 2011-09-19 | 2012-09-12 | 261d? | finish no earlier than 2012-09-12 | S3 | 2080h | 2080h | SIMTC-Priv | 27 | TBD | Samsung | Rel-11 | 53 | Mirko | PCG-29 | CP-57 | MTC, M2M | SIMTC-Priv |
| 5513 | 1805.14 | Deleted - Stage 2 on SA2 part for System Improvements to Machine-Type Communications |  | 260d? | 2010-06-10 A | 2011-06-08 A | 100% | 2010-06-10 | 2011-06-08 | 260d? | finish no earlier than 2011-06-08 | S2 | 2080h | 2080h | SIMTC | 25 | TBD | Intel | Rel-11 | 48 | Maurice | PCG-27 | SP-52 | MTC, M2M |  |
| 5514 | 1805.15 | Deleted - Stage 2 on Security part for System Improvements to Machine-Type Communications |  | 260d? | 2010-06-10 A | 2011-06-08 A | 100% | 2010-06-10 | 2011-06-08 | 260d? | finish no earlier than 2011-06-08 | S3 | 2080h | 2080h | SIMTC | 25 | TBD | Samsung | Rel-11 | 48 | Mirko | PCG-27 | SP-52 | MTC, M2M |  |
| 5515 | 1806 | **Unstructured Supplementary Service Data (USSD) simulation service in IMS** |  | 659d? | 2010-06-10 A | 2012-12-07 A | 100% | 2010-06-10 | 2012-12-07 | 659d? |  | S1; C1; C3 | 28112.1h | 28112.1h | USSI | 25 |  | Deutsche Telekom | Rel-11 | 48 | Alain |  |  |  | USSI |
| 5516 | 1806.1 | Stage 1 for USSD simulation service in IMS | milestone | 0d? | 2010-06-10 A | 2010-06-10 A | 100% | 2010-06-10 | 2010-06-10 | 0d? | finish no earlier than 2010-06-10 | S1 |  |  | USSI | 25 | 22.173 | Deutsche Telekom | Rel-11 | 48 | Alain |  |  |  |  |
| 5517 | 1806.2 | **Stage 3 for USSD simulation service in IMS** |  | 403d? | 2011-06-03 A | 2012-12-07 A | 100% | 2011-06-03 | 2012-12-07 | 403d? |  | C1; C3 | 12296.1h | 12296.1h | USSI | 27 |  | Deutsche Telekom | Rel-11 | 52 | Frederic |  |  |  |  |
| 5518 | 1806.2.1 | CT1 part of Stage 3 for USSD simulation service in IMS |  | 402d? | 2011-06-03 A | 2012-12-07 A | 100% | 2011-06-03 | 2012-12-07 | 402d? | finish no earlier than 2012-12-07 | C1 | 3184.06h | 3184.06h | USSI | 27 | 24.173; 24.229; new 24.390 | Deutsche Telekom | Rel-11 | 52 | Frederic |  |  |  |  |
| 5519 | 1806.2.2 | CT3 part of Stage 3 for USSD simulation service in IMS |  | 334d? | 2011-06-07 A | 2012-09-07 A | 100% | 2011-06-07 | 2012-09-07 | 334d? | finish no earlier than 2012-09-07 | C3 | 2664h | 2664h | USSI | 27 | 29.165 | Deutsche Telekom | Rel-11 | 52 | Adrian |  |  |  |  |
| 5520 | 1807 | **QoS Control Based on Subscriber Spending Limits** |  | 459d? | 2010-09-23 A | 2012-06-20 A | 100% | 2010-09-23 | 2012-06-20 | 459d? |  | S1; S2; S5; C3 | 23152h | 23152h | QoS_SSL | 25 |  | Vodafone | Rel-11 | 49 | Alain |  |  |  | QoS_SSL |
| 5521 | 1807.1 | Stage 1 for QoS Control Based on Subscriber Spending Limits |  | 262d? | 2010-09-23 A | 2011-09-21 A | 100% | 2010-09-23 | 2011-09-21 | 262d? | finish no earlier than 2011-09-21 | S1 | 2080h | 2080h | QoS_SSL | 25 | 22.115 | Vodafone | Rel-11 | 49 | Alain |  |  |  |  |
| 5522 | 1807.2 | Stage 2 for QoS Control Based on Subscriber Spending Limits |  | 133d? | 2011-03-23 A | 2011-09-21 A | 100% | 2011-03-23 | 2011-09-21 | 133d? | finish no earlier than 2011-12-14 | S2 | 1048h | 1048h | QoS_SSL | 26 | 23.203 | Huawei | Rel-11 | 51 | Maurice |  |  |  |  |
| 5523 | 1807.3 | Charging for QoS Control Based on Subscriber Spending Limits (Stage 2) |  | 397d? | 2010-12-16 A | 2012-06-20 A | 100% | 2010-12-16 | 2012-06-20 | 397d? | finish no earlier than 2012-06-20 | S5 | 3168h | 3168h | QoS_SSL | 26 | 32.240; 32.296 | Nokia Siemens Networks, Huawei | Rel-11 | 50 | Mirko |  |  |  |  |
| 5524 | 1807.4 | CT3 aspects of QoS Control Based on Subscriber Spending Limits (Stage 3) |  | 273d? | 2011-06-03 A | 2012-06-15 A | 100% | 2011-06-03 | 2012-06-15 | 273d? | finish no earlier than 2012-06-15 | C3 | 2168h | 2168h | QoS_SSL-CT3 | 27 | 29.212; 29.213; 29.214; 29.215; new 29.219 | Huawei | Rel-11 | 52 | Adrian |  |  |  | QoS_SSL-CT3 |
| 5525 | 1808 | **Optimized Service Charging and Allocation of Resources in IMS whilst Roaming** |  | 383d? | 2010-09-23 A | 2012-03-07 A | 100% | 2010-09-23 | 2012-03-07 | 383d? |  | S1; S2 | 14288h | 14288h | OSCAR | 25 |  | Vodafone | Rel-11 | 49 | Alain |  |  |  | OSCAR |
| 5526 | 1808.1 | TR on Stage 2 aspects of Optimized Service Charging and Allocation of Resources in IMS whilst Roaming |  | 383d? | 2010-09-23 A | 2012-03-07 A | 100% | 2010-09-23 | 2012-03-07 | 383d? | finish no earlier than 2011-12-07 | S2 | 3040h | 3040h | OSCAR | 25 | new 23.849 | Vodafone | Rel-11 | 49 | Maurice |  |  |  |  |
| 5527 | 1808.2 | Stage 1 for Optimized Service Charging and Allocation of Resources in IMS whilst Roaming |  | 262d? | 2010-09-23 A | 2011-09-21 A | 100% | 2010-09-23 | 2011-09-21 | 262d? | finish no earlier than 2011-09-21 | S1 | 2080h | 2080h | OSCAR | 25 | 22.115; 22.173; 22.228 | Vodafone | Rel-11 | 49 | Alain |  |  |  |  |
| 5528 | 1808.3 | Deleted - Stage 2 for Optimized Service Charging and Allocation of Resources in IMS whilst Roaming |  | 380d? | 2010-09-28 A | 2012-03-07 A | 100% | 2010-09-28 | 2012-03-07 | 380d? | finish no earlier than 2012-03-07 | S2 | 3040h | 3040h | OSCAR | 25 | None | Vodafone | Rel-11 | 49 | Maurice | PCG-28 | SP-55 |  |  |
| 5529 | 1809 | **Inclusion of Media Resource Broker (Stage 2/3)** |  | 463d? | 2011-09-16 A | 2013-06-14 A | 100% | 2011-09-16 | 2013-06-14 | 463d? |  | C1; C3; IETF | 30500h | 30500h | MRB | 27 | Stage 2/3 | AT&T | Rel-11 | 53 | Frederic |  |  |  | MRB |
| 5530 | 1809.1 | Stage 2 for Inclusion of Media Resource Broker |  | 259d? | 2011-09-16 A | 2012-09-07 A | 100% | 2011-09-16 | 2012-09-07 | 259d? | finish no earlier than 2012-09-07 | C1 | 2049.98h | 2049.98h | MRB | 27 | 23.218 | AT&T | Rel-11 | 53 | Frederic |  |  |  |  |
| 5531 | 1809.2 | **Stage 3 for Inclusion of Media Resource Broker** |  | 463d? | 2011-09-16 A | 2013-06-14 A | 100% | 2011-09-16 | 2013-06-14 | 463d? |  | C1; C3; IETF | 17338h | 17338h | MRB | 27 |  | AT&T | Rel-11 | 53 | Frederic |  |  |  |  |
| 5532 | 1809.2.1 | CT1 part of Stage 3 for Inclusion of Media Resource Broker |  | 258d? | 2011-09-16 A | 2012-09-07 A | 100% | 2011-09-16 | 2012-09-07 | 258d? | finish no earlier than 2012-09-07 | C1 | 2049.98h | 2049.98h | MRB | 27 | 24.229; 29.165 | AT&T | Rel-11 | 53 | Frederic |  |  |  |  |
| 5533 | 1809.2.2 | (IETF) Inclusion of Media Resource Broker [RFC 6917 (was draft-ietf-mediactrl-mrb)] |  | 462d? | 2011-09-16 A | 2013-06-14 A | 100% | 2011-09-16 | 2013-06-14 | 462d? | finish no earlier than 2013-06-14 | C1-IETF | 3688h | 3688h | MRB | 27 | RFC 6917 (was draft-ietf-mediactrl-mrb) | Keith Drage | Rel-11 | 53 | Frederic |  |  |  |  |
| 5534 | 1809.2.3 | CT3 part of Stage 3 for Inclusion of Media Resource Broker |  | 62d? | 2012-06-15 A | 2012-09-07 A | 100% | 2012-06-15 | 2012-09-07 | 62d? | finish no earlier than 2012-09-07 | C3 | 488h | 488h | MRB | 29 | 29.165 | AT&T | Rel-11 | 56 | Adrian |  |  |  |  |

Notes:
- 5510: SP#57 stopped (activity transferred to Rel-12 Feature MTCe under UID_560522) / WI rapporteur e-mail: Rajavelsamy R (rajvel@samsung.com)
- 5511: SP#57 stopped (activity transferred to Rel-12 Feature MTCe / WI rapporteur e-mail: Rajavelsamy R (rajvel@samsung.com)
- 5512: SP#57 stopped (activity transferred to Rel-12 Feature MTCe / WI rapporteur e-mail: Rajavelsamy R (rajvel@samsung.com)
- 5513: SP#52 stopped / WI rapporteur e-mail: puneet.jain@intel.com
- 5514: SP#52 stopped / WI rapporteur e-mail: Rajavelsamy R (rajvel@samsung.com)
- 5515: CP#58 completed / WI rapporteur e-mail: kurt.bischinger@t-mobile.at
- 5516: SP#48 completed. Specify a CS domain USSD like service over IMS (see GSM Mobile User Initiated USSD) / WI rapporteur e-mail: kurt.bischinger@t-mobile.at
- 5517: SP#58 completed. No stage 2 impact, as reuse existing IMS architecture in TS 23.228 / WI rapporteur e-mail: reinhard.lauster@t-mobile.at
- 5518: CP#58 completed / WI rapporteur e-mail: reinhard.lauster@t-mobile.at, TS 24.390 Rapp: lili.yang@huawei.com
- 5519: CP#57 completed / WI rapporteur e-mail: reinhard.lauster@t-mobile.at
- 5520: TSG#56 completed / WI rapporteur e-mail: mona.mustapha@vodafone.com
- 5521: SP#53 completed. Use cases & service requirements to allow: 1) modification of QoS based on subscribers spending limits 2) enforcing of spending limits for roaming subscribers without having dedicated support in the visited network / WI rapporteur e-mail: mona.mustapha@vodafone.com
- 5522: SP#53 completed / WI rapporteur e-mail: Xu Xia (xiatony@huawei.com)
- 5523: SP#56 completed / WI rapporteur e-mail: Gerald.Goermer@nsn.com, shan.mingjun@huawei.com
- 5524: CP#56 completed / WI rapporteur e-mail: QiaoWeihua@huawei.com
- 5525: SP#55 completed (Stage 2/3 specified under CT1 Rel-11 Feature MRB (Inclusion of Media Resource Broker) UID_530021. Triggered by S1-102236/GSMA RILTE 10_007r1 (IREG LS_038 to 3GPP on Optimal Media Routing drawbacks) / WI rapporteur e-mail: mona.mustapha@vodafone.com
- 5526: SP#55 completed / WI rapporteur e-mail: Susana.Sabater@vodafone.com
- 5527: SP#53 completed / WI rapporteur e-mail: mona.mustapha@vodafone.com
- 5528: SP#55 no normative work in SA2. Stage 2/3 to be done in under CT1 Rel-11 Feature MRB (Inclusion of Media Resource Broker) UID_530021 / WI rapporteur e-mail: Susana.Sabater@vodafone.com
- 5529: Stage 1 and TR on Stage 2 in Rel-11 Feature OSCAR UID_490032 / WI rapporteur e-mail: Martin Dolly (md3135@att.com)
- 5530: CP#57 completed / WI rapporteur e-mail: Martin Dolly (md3135@att.com)
- 5531: CP#60 completed / WI rapporteur e-mail: Martin Dolly (md3135@att.com)
- 5532: CP#57 completed / WI rapporteur e-mail: Martin Dolly (md3135@att.com)
- 5533: CP#60 completed
- 5534: CP#57 completed / WI rapporteur e-mail: Martin Dolly (md3135@att.com)

| ID | WBS | Task | Duration | Start | Finish | Complete | Baseline start | Baseline finish | Baseline duration | Constraint | Resources | Work | Actual work | Acronym | PCG approved | WI rapporteur name | WI rapporteur e-mail | Release | TSG approved | MCC resp | Acronym_3GU_Export | Special Focus Doc | PCG stopped | TSG stopped |
| --- | --- | --- | --- | --- | --- | --- | --- | --- | --- | --- | --- | --- | --- | --- | --- | --- | --- | --- | --- | --- | --- | --- | --- | --- |
| 5535 | 1810 | **Non Voice Emergency Services** | 323d? | 2010-12-16 A | 2012-03-07 A | 100% | 2010-12-16 | 2012-03-07 | 323d? |  | S1; S2 | 7736h | 7736h | NOVES | 26 | Qualcomm | dwilliams@qualcomm.com | Rel-11 | 50 | Alain | NOVES |  |  |  |
| 5536 | 1810.1 | Stage 1 for Non Voice Emergency Services | 202d? | 2010-12-16 A | 2011-09-21 A | 100% | 2010-12-16 | 2011-09-21 | 202d? | finish no earlier than 2011-09-21 | S1 | 1600h | 1600h | NOVES | 26 | Qualcomm | dwilliams@qualcomm.com | Rel-11 | 50 | Alain |  |  |  |  |
| 5537 | 1810.2 | Stage 2 for Non Voice Emergency Services (Support of IMS Emergency Sessions with Other Media on UTRAN and E-UTRAN) | 121d? | 2011-09-22 A | 2012-03-07 A | 100% | 2011-09-22 | 2012-03-07 | 121d? | finish no earlier than 2012-03-07 | S2 | 968h | 968h | NOVES-IMSESOM | 27 | Alcatel-Lucent | Deb.Barclay@alcatel-lucent.com | Rel-11 | 53 | Maurice | NOVES-IMSESOM |  |  |  |
| 5538 | 1811 | **Support for 3GPP Voice Interworking with Enterprise IP-PBX** | 516d? | 2011-03-23 A | 2013-03-01 A | 100% | 2011-03-23 | 2013-03-01 | 516d? |  | S1; C1 | 12376h | 12376h | VINE | 26 | Tatara Systems | Phillip Brown (pbrown@tatarasystems.com) | Rel-11 | 51 | Alain | VINE |  |  |  |
| 5539 | 1811.1 | Stage 1 for Support for 3GPP Voice Interworking with Enterprise IP-PBX | 133d? | 2011-03-23 A | 2011-09-21 A | 100% | 2011-03-23 | 2011-09-21 | 133d? | finish no earlier than 2011-09-21 | S1 | 1048h | 1048h | VINE | 26 | Tatara Systems | Phillip Brown (pbrown@tatarasystems.com) | Rel-11 | 51 | Alain |  |  |  |  |
| 5540 | 1811.2 | Stage 2/3 for Support for 3GPP Voice Interworking with Enterprise IP-PBX | 385d? | 2011-09-20 A | 2013-03-01 A | 100% | 2011-09-20 | 2013-03-01 | 385d? | finish no earlier than 2013-03-01 | C1 | 3072h | 3072h | VINE-CT1 | 27 | Alcatel-Lucent | keith.drage@alcatel-lucent.com | Rel-11 | 53 | Frederic | VINE-CT1 |  |  |  |
| 5541 | 1812 | **Anonymous Call Rejection in the CS domain** | 132d? | 2011-06-07 A | 2011-12-02 A | 100% | 2011-06-07 | 2011-12-02 | 132d? |  | S1; C4; C3 | 4616h | 4616h | ACR_CS | 27 | Alcatel-Lucent | Betsy.Covell@alcatel-lucent.com | Rel-11 | 52 | Alain | ACR_CS |  |  |  |
| 5542 | 1812.1 | Stage 1 for Anonymous Call Rejection in the CS domain | 2d? | 2011-06-07 A | 2011-06-08 A | 100% | 2011-06-07 | 2011-06-08 | 2d? | finish no earlier than 2011-06-07 | S1 | 16h | 16h | ACR_CS | 27 | Alcatel-Lucent | Betsy.Covell@alcatel-lucent.com | Rel-11 | 52 | Alain |  |  |  |  |
| 5543 | 1812.2 | **Core Network aspects of Anonymous Call Rejection in the CS domain** | 59d? | 2011-09-14 A | 2011-12-02 A | 100% | 2011-09-14 | 2011-12-02 | 59d? |  | C4; C3 | 1432h | 1432h | ACR_CS-CN | 27 | Alcatel-Lucent | bruno.landais@alcatel-lucent.com | Rel-11 | 53 | Kimmo | ACR_CS-CN |  |  |  |
| 5544 | 1812.2.1 | CT4 part of Core Network aspects of Anonymous Call Rejection in the CS domain (Stage 2/3) | 59d? | 2011-09-14 A | 2011-12-02 A | 100% | 2011-09-14 | 2011-12-02 | 59d? | finish no earlier than 2011-12-02 | C4 | 464h | 464h | ACR_CS-CN | 27 | Alcatel-Lucent | bruno.landais@alcatel-lucent.com | Rel-11 | 53 | Kimmo |  |  |  |  |
| 5545 | 1812.2.2 | CT3 part of Core Network aspects of Anonymous Call Rejection in the CS domain (Stage 3) | 3d? | 2011-09-14 A | 2011-09-16 A | 100% | 2011-09-14 | 2011-09-16 | 3d? | start no earlier than 2011-09-14 | C3 | 24h | 24h | ACR_CS-CN | 27 | Alcatel-Lucent | bruno.landais@alcatel-lucent.com | Rel-11 | 53 | Adrian |  |  |  |  |
| 5546 | 1813 | **Support for BroadBand Forum Accesses Interworking** | 792d? | 2009-12-10 A | 2012-12-12 A | 100% | 2009-12-10 | 2012-12-12 | 792d? |  | S2; S1; C1; C3; C4; IETF | 97983.8h | 97983.8h | BBAI | 24 | Ericsson | peter.bleckert@ericsson.com | Rel-11 | 46 | Alain | BBAI | HNB, WLAN |  |  |
| 5547 | 1813.1 | Stage 1 BB I: BBF interworking with home routed traffic for WLAN and H(e)NB | 76d? | 2009-12-10 A | 2010-03-25 A | 100% | 2009-12-10 | 2010-03-25 | 76d? | start no earlier than 2009-12-10 | S1 | 608h | 608h | BBAI | 24 | Ericsson | Olle.Eriksson@ericsson.com | Rel-11 | 46 | Alain |  | HNB, WLAN |  |  |
| 5548 | 1813.2 | TR on Stage 2 for BBAI | 588d? | 2010-03-26 A | 2012-06-20 A | 100% | 2010-03-26 | 2012-06-20 | 588d? | finish no earlier than 2012-06-19 | S2 | 4704h | 4704h | BBAI | 24 | Ericsson | marco.spini@huawei.com | Rel-11 | 47 | Maurice |  | HNB, WLAN |  |  |
| 5549 | 1813.3 | Stage 2 BB I: BBF interworking with home routed traffic for WLAN and H(e)NB | 588d? | 2010-03-26 A | 2012-06-20 A | 100% | 2010-03-26 | 2012-06-20 | 588d? | finish no earlier than 2012-06-20 | S2 | 4688.06h | 4688.06h | BBAI | 24 | Ericsson | stefan.rommer@ericsson.com | Rel-11 | 47 | Maurice |  | HNB, WLAN |  |  |
| 5550 | 1813.4 | (IETF) Stage 2 BB I: BBF interworking with home routed traffic for WLAN and H(e)NB | 266d? | 2011-12-12 A | 2012-12-12 A | 100% | 2011-12-12 | 2012-12-12 | 266d? | finish no earlier than 2012-11-24 | S2-IETF | 2119.59h | 2119.59h | BBAI | 28 | Lionel Morand | Lionel Morand | Rel-11 | 54 | Maurice |  | HNB, WLAN |  |  |
| 5551 | 1813.5 | **Stage 3 BB I - Core Network impacts: BBF interworking with home routed traffic for WLAN and H(e)NB** | 326d? | 2011-09-16 A | 2012-12-07 A | 100% | 2011-09-16 | 2012-12-07 | 326d? |  | C1; C3; C4 | 17288.2h | 17288.2h | BBAI_BBI-CT | 27 | Ericsson | Zu.Qiang@Ericsson.com | Rel-11 | 53 | Frederic | BBAI_BBI-CT | HNB, WLAN |  |  |
| 5552 | 1813.5.1 | TR on Stage 3 BB I for BBAI; UE to network protocols | 198d? | 2011-09-16 A | 2012-06-15 A | 100% | 2011-09-16 | 2012-06-15 | 198d? | finish no earlier than 2012-06-15 | C1 | 1568.15h | 1568.15h | BBAI_BBI-CT | 27 | Ericsson | Zu.Qiang@Ericsson.com | Rel-11 | 53 | Frederic |  | HNB, WLAN |  |  |
| 5553 | 1813.5.2 | TR on Stage 3 BB I for BBAI; Home (e)Node B – Security Gateway Interface | 77d? | 2012-03-02 A | 2012-06-15 A | 100% | 2012-03-02 | 2012-06-15 | 77d? | finish no earlier than 2012-06-01 | C4 | 608h | 608h | BBAI_BBI-CT | 28 | Ericsson | Zu.Qiang@Ericsson.com | Rel-11 | 55 | Kimmo |  | HNB, WLAN |  |  |
| 5554 | 1813.5.3 | Deleted - (IETF) on Stage 3 BB I for BBAI; Home (e)Node B – Security Gateway Interface | 77d? | 2012-03-02 A | 2012-06-15 A | 100% | 2012-03-02 | 2012-06-15 | 77d? | finish no earlier than 2012-06-15 | C4-IETF | 616h | 616h | BBAI_BBI-CT | 28 | Lionel Morand |  | Rel-11 | 55 | Kimmo |  | HNB, WLAN | PCG-29 | CP-56 |
| 5555 | 1813.5.4 | CT1 part of Stage 3 BB I: BBF interworking with home routed traffic for WLAN and H(e)NB | 258d? | 2011-09-16 A | 2012-09-07 A | 100% | 2011-09-16 | 2012-09-07 | 258d? | finish no earlier than 2012-09-07 | C1 | 2048h | 2048h | BBAI_BBI-CT | 27 | Ericsson | Zu.Qiang@Ericsson.com | Rel-11 | 53 | Frederic |  | HNB, WLAN |  |  |
| 5556 | 1813.5.5 | CT3 part of Stage 3 BB I: BBF interworking with home routed traffic for WLAN and H(e)NB | 259d? | 2011-09-16 A | 2012-09-07 A | 100% | 2011-09-16 | 2012-09-07 | 259d? | finish no earlier than 2012-09-07 | C3 | 2048h | 2048h | BBAI_BBI-CT | 27 | Ericsson | Zu.Qiang@Ericsson.com | Rel-11 | 53 | Adrian |  | HNB, WLAN |  |  |
| 5557 | 1813.5.6 | CT4 part of Stage 3 BB I: BBF interworking with home routed traffic for WLAN and H(e)NB | 326d? | 2011-09-16 A | 2012-12-07 A | 100% | 2011-09-16 | 2012-12-07 | 326d? | finish no earlier than 2012-12-07 | C4 | 2576h | 2576h | BBAI_BBI-CT | 27 | Ericsson | Zu.Qiang@Ericsson.com | Rel-11 | 53 | Kimmo |  | HNB, WLAN |  |  |
| 5558 | 1813.6 | Stage 1 BB II: BBF interworking with offload in access network for WLAN and for H(e)NB | 262d? | 2010-09-23 A | 2011-09-21 A | 100% | 2010-09-23 | 2011-09-21 | 262d? | finish no earlier than 2011-09-21 | S1 | 2080h | 2080h | BBAI_BBII-CTofldS1 | 25 | Ericsson | Olle.Eriksson@ericsson.com | Rel-11 | 49 | Alain |  | HNB, WLAN |  |  |
| 5559 | 1813.7 | Stage 2 BB II: BBF interworking with offload in access network for WLAN and for H(e)NB | 455d? | 2010-09-28 A | 2012-06-20 A | 100% | 2010-09-28 | 2012-06-20 | 455d? | finish no earlier than 2012-06-20 | S2 | 3640h | 3640h | BBAI_BBII-CTofldS2 | 24 | Ericsson | stefan.rommer@ericsson.com | Rel-11 | 47 | Maurice |  | HNB, WLAN |  |  |

Notes:
- 5535: SP#55 Stage 2 completed. Triggered by SA1 Rel-11 TR 22.871 Study on Non Voice Emergency Services (FS_NOVES)
- 5536: SP#53 completed / Impacted TSs and TRs: 22.101
- 5537: SP#55 completed / Impacted TSs and TRs: 23.060; 23.167; 23.203; 23.401
- 5538: SP#53 Stage 1 completed. CP#59 completed. Triggered by Rel-11 TR 22.809 Study on Support for 3GPP Voice Interworking with Enterprise IP-PBX (FS_VINE) UID_480033
- 5539: SP#53 completed / Impacted TSs and TRs: 22.228
- 5540: CP#59 completed / Impacted TSs and TRs: 23.218; 24.229
- 5541: CP#54 completed
- 5542: SP#52 completed under TEI11. Approved WID and CRs in SP-110376 (22.082 CR#0005, 22.085 CR#0004, 22.081 CR#0007, 22.088 CR#0003, 22.004 CR#0013) / Impacted TSs and TRs: 22.004; 22.081; 22.082; 22.085; 22.088
- 5543: CP#54 completed / Impacted TSs and TRs: Stage 2/3
- 5544: CP#54 completed / Impacted TSs and TRs: 23.018; 23.081; 23.082; 23.085; 23.088; 23.205; 23.231; 24.088; 29.002; 29.011
- 5545: CP#53 completed / Impacted TSs and TRs: 29.163; 29.292
- 5546: SP#57 updated WID SP-120419=>SP-120539 (removed BB3 objectives not implemented in Stage 2). SP#56 completed. Triggered by BBF WT 203, WT-134 (interworking btw 3GPP EPS and BBF's fixed broadband accesses)
- 5547: SP#57 updated WID SP-120419=>SP-120539 (removed BB3 objectives not implemented in Stage 2). SP#47 completed. Provide service requirements for supporting interworking between 3GPP EPS and the fixed broadband accesses defined by BBF / Impacted TSs and TRs: 22.278 CR#0058
- 5548: TR 23.839 not Approved in Rel-11¦progressed in Rel-12 under P4C-TI (UID_560824) / Impacted TSs and TRs: new 23.839
- 5549: SP#56 completed / Impacted TSs and TRs: 23.203; new 23.139
- 5550: Solved by IANA-registration. No RFC needed
- 5551: CP#58 completed / Impacted TSs and TRs: Stage 3
- 5552: CP#56 completed. Identify additional FMC specific procedurES in CP-150addition to those in 24.302 (on access authentication & authorization and tunnel management¦IP mobility mode selection¦security aspects) / Impacted TSs and TRs: new 24.820
- 5553: CP#56 completed / Impacted TSs and TRs: new 29.839
- 5554: Draft removed from 3GPP documentation / Impacted TSs and TRs: draft-so-ipsecme-ikev2-cpext
- 5555: CP#57 completed / Impacted TSs and TRs: 24.229; new 24.139
- 5556: CP#57 completed / Impacted TSs and TRs: 29.212; 29.213; 29.215
- 5557: CP#58 completed / Impacted TSs and TRs: 23.008; 29.273; 29.274; new 29.139
- 5558: SP#53 completed. 22/01: acronym modified / Impacted TSs and TRs: 22.278
- 5559: SP#56 completed. 22/01: acronym modified / Impacted TSs and TRs: 23.203; 23.401; 23.402; 23.139

| ID | WBS | Task | Duration | Start | Finish | Complete | Baseline start | Baseline finish | Baseline duration | Constraint | Resources | Work | Actual work | Acronym | PCG approved | Impacted TSs and TRs | WI rapporteur name | WI rapporteur e-mail | Release | TSG approved | MCC resp | Special Focus Doc | Acronym_3GU_Export | PCG stopped | TSG stopped |
| --- | --- | --- | --- | --- | --- | --- | --- | --- | --- | --- | --- | --- | --- | --- | --- | --- | --- | --- | --- | --- | --- | --- | --- | --- | --- |
| 5560 | 1813.8 | **Stage 3 BB II - Core Network impacts: BBF interworking with offload in access network for WLAN and for H(e)NB** | 259d? | 2011-09-16 A | 2012-09-07 A | 100% | 2011-09-16 | 2012-09-07 | 259d? |  | C3; C1; C4 | 12888h | 12888h | BBAI_BBII-CT | 27 | Stage 3 | Ericsson | Susana.Fernandez@ericsson.com | Rel-11 | 53 | Adrian | HNB, WLAN | BBAI_BBII-CT |  |  |
| 5561 | 1813.8.1 | TR on Stage 3 BB II for 3GPP System to Fixed Broadband Access Network Interworking; UE to network protocols | 198d? | 2011-09-16 A | 2012-06-15 A | 100% | 2011-09-16 | 2012-06-15 | 198d? | finish no earlier than 2012-06-15 | C1 | 1576h | 1576h | BBAI_BBII-CT | 27 | 24.820 | Ericsson | Susana.Fernandez@ericsson.com | Rel-11 | 53 | Frederic | HNB, WLAN |  |  |  |
| 5562 | 1813.8.2 | CT1 part of Stage 3 BB II: BBF interworking with offload in access network for WLAN and for H(e)NB | 259d? | 2011-09-16 A | 2012-09-07 A | 100% | 2011-09-16 | 2012-09-07 | 259d? | finish no earlier than 2012-09-07 | C1 | 2064h | 2064h | BBAI_BBII-CT | 27 | new 24.320 | Ericsson | Susana.Fernandez@ericsson.com | Rel-11 | 53 | Frederic | HNB, WLAN |  |  |  |
| 5563 | 1813.8.3 | CT3 part of Stage 3 BB II: BBF interworking with offload in access network for WLAN and for H(e)NB | 259d? | 2011-09-16 A | 2012-09-07 A | 100% | 2011-09-16 | 2012-09-07 | 259d? | start no earlier than 2011-09-16 | C3 | 2056h | 2056h | BBAI_BBII-CT | 27 | 29.212; 29.213; 29.215 | Ericsson | Susana.Fernandez@ericsson.com | Rel-11 | 53 | Adrian | HNB, WLAN |  |  |  |
| 5564 | 1813.8.4 | CT4 part of Stage 3 BB II: BBF interworking with offload in access network for WLAN and for H(e)NB | 122d? | 2011-09-16 A | 2012-03-02 A | 100% | 2011-09-16 | 2012-03-02 | 122d? | start no earlier than 2011-09-16 | C4 | 976h | 976h | BBAI_BBII-CT | 27 | 23.008; 29.273 | Ericsson | Susana.Fernandez@ericsson.com | Rel-11 | 53 | Kimmo | HNB, WLAN |  |  |  |
| 5565 | 1813.9 | Deleted - Stage 1 BB III: BBF convergence and network based mobility | 262d? | 2010-09-23 A | 2011-09-21 A | 100% | 2010-09-23 | 2011-09-21 | 262d? | finish no earlier than 2011-09-21 | S1 | 2080h | 2080h |  | 25 | 22.278 | Huawei | Amar Deol (adeol@huawei.com) | Rel-11 | 49 | Alain | HNB, WLAN |  | PCG-29 | SP-57 |
| 5566 | 1813.10 | Deleted - Stage 2 BB III: BBF convergence and network based mobility | 380d? | 2010-09-28 A | 2012-03-07 A | 100% | 2010-09-28 | 2012-03-07 | 380d? | finish no earlier than 2012-03-07 | S2 | 3040h | 3040h |  | 24 | 23.203; 23.401; 23.402; 23.139 | Huawei | marco.spini@huawei.com | Rel-11 | 47 | Maurice | HNB, WLAN |  | PCG-28 | SP-55 |
| 5567 | 1813.11 | **Deleted - Stage 3 BB III - Core Network impacts: BBF convergence and network based mobility** | 122d? | 2011-09-16 A | 2012-03-02 A | 100% | 2011-09-16 | 2012-03-02 | 122d? |  | C3; C1; C4 | 6832h | 6832h |  | 27 | Stage 3 | Huawei | qiaoweihua@huawei.com | Rel-11 | 53 | Adrian | HNB, WLAN | BBAI_BBIII-CT | PCG-28 | CP-55 |
| 5568 | 1813.11.1 | Deleted - TR on Stage 3 BB III for 3GPP System to Fixed Broadband Access Network Interworking; UE to network protocols | 122d? | 2011-09-16 A | 2012-03-02 A | 100% | 2011-09-16 | 2012-03-02 | 122d? | start no earlier than 2011-09-16 | C1 | 976h | 976h |  | 27 | new 24.820 | Huawei | qiaoweihua@huawei.com | Rel-11 | 53 | Frederic | HNB, WLAN |  | PCG-28 | CP-55 |
| 5569 | 1813.11.2 | Deleted - CT1 part of Stage 3 BB III: BBF convergence and network based mobility | 122d? | 2011-09-16 A | 2012-03-02 A | 100% | 2011-09-16 | 2012-03-02 | 122d? | start no earlier than 2011-09-16 | C1 | 976h | 976h |  | 27 | TBD | Huawei | qiaoweihua@huawei.com | Rel-11 | 53 | Frederic | HNB, WLAN |  | PCG-28 | CP-55 |
| 5570 | 1813.11.3 | Deleted - CT3 part of Stage 3 BB III: BBF convergence and network based mobility | 122d? | 2011-09-16 A | 2012-03-02 A | 100% | 2011-09-16 | 2012-03-02 | 122d? | start no earlier than 2011-09-16 | C3 | 976h | 976h |  | 27 | 29.212; 29.213; 29.215 | Huawei | qiaoweihua@huawei.com | Rel-11 | 53 | Adrian | HNB, WLAN |  | PCG-28 | CP-55 |
| 5571 | 1813.11.4 | Deleted - CT4 part of Stage 3 BB III: BBF convergence and network based mobility | 122d? | 2011-09-16 A | 2012-03-02 A | 100% | 2011-09-16 | 2012-03-02 | 122d? | start no earlier than 2011-09-16 | C4 | 976h | 976h |  | 27 | 23.008; 29.273 | Huawei | qiaoweihua@huawei.com | Rel-11 | 53 | Kimmo | HNB, WLAN |  | PCG-28 | CP-55 |
| 5572 | 1814 | **Single Radio Voice Call Continuity (SRVCC) aspect of enhancements for Multimedia Priority Service** | 398d? | 2010-06-10 A | 2011-12-14 A | 100% | 2010-06-10 | 2011-12-14 | 398d? |  | S2 | 8432h | 8432h | eMPS_SRVCC | 25 | Stage 2 | NTT DoCoMo | Atsushi Minokuchi (minokuchi@nttdocomo.co.jp) | Rel-11 | 48 | Maurice | Public Safety (I-A) | eMPS_SRVCC |  |  |
| 5573 | 1814.1 | TR on SRVCC for eMPS | 260d? | 2010-06-10 A | 2011-06-08 A | 100% | 2010-06-10 | 2011-06-08 | 260d? | finish no earlier than 2011-06-08 | S2 | 2080h | 2080h | eMPS_SRVCC | 25 | new 23.854 | NTT DoCoMo | Atsushi Minokuchi (minokuchi@nttdocomo.co.jp) | Rel-11 | 48 | Maurice | Public Safety (I-A) |  |  |  |
| 5574 | 1814.2 | Stage 2 on SRVCC for eMPS | 398d? | 2010-06-10 A | 2011-12-14 A | 100% | 2010-06-10 | 2011-12-14 | 398d? | finish no earlier than 2011-12-14 | S2 | 3168h | 3168h | eMPS_SRVCC | 25 | 23.216; 23.237 | NTT DoCoMo | Atsushi Minokuchi (minokuchi@nttdocomo.co.jp) | Rel-11 | 48 | Maurice | Public Safety (I-A) |  |  |  |
| 5575 | 1815 | **Single Radio Video Call Continuity for 3G-CS** | 440d? | 2010-10-15 A | 2012-06-15 A | 100% | 2010-10-15 | 2012-06-15 | 440d? |  | S2; C1; C3; C4 | 26572.4h | 26572.4h | vSRVCC | 26 |  | Samsung | xiaowan.ke@samsung.com | Rel-11 | 50 | Maurice |  | vSRVCC |  |  |
| 5576 | 1815.1 | Stage 2 for Single Radio Video Call Continuity for 3G-CS | 199.85d? | 2010-10-15 A | 2011-09-21 A | 100% | 2010-10-15 | 2011-09-21 | 199.85d? | finish no earlier than 2011-12-07 | S2 | 1580.41h | 1580.41h | vSRVCC | 26 | 23.203; 23.216; 23.237 | Samsung | xiaowan.ke@samsung.com | Rel-11 | 50 | Maurice |  |  |  |  |
| 5577 | 1815.2 | **CN aspects of Single Radio Video Call Continuity for 3G-CS** | 275d? | 2011-06-03 A | 2012-06-15 A | 100% | 2011-06-03 | 2012-06-15 | 275d? |  | C1; C3; C4 | 10912h | 10912h | vSRVCC-CT | 27 |  | NEC | gottfried.punz@neclab.eu | Rel-11 | 52 | Frederic |  | vSRVCC-CT |  |  |
| 5578 | 1815.2.1 | CT1 aspects of Single Radio Video Call Continuity for 3G-CS | 275d? | 2011-06-03 A | 2012-06-15 A | 100% | 2011-06-03 | 2012-06-15 | 275d? | finish no earlier than 2012-06-15 | C1 | 2184h | 2184h | vSRVCC-CT | 27 | 24.008; 24.237; 24.301 | NEC | gottfried.punz@neclab.eu | Rel-11 | 52 | Frederic |  |  |  |  |
| 5579 | 1815.2.2 | CT3 aspects of Single Radio Video Call Continuity for 3G-CS | 134d? | 2011-06-03 A | 2011-12-02 A | 100% | 2011-06-03 | 2011-12-02 | 134d? | finish no earlier than 2011-12-02 | C3 | 1064h | 1064h | vSRVCC-CT | 27 | 29.211; 29.212; 29.213; 29.215 | NEC | gottfried.punz@neclab.eu | Rel-11 | 52 | Adrian |  |  |  |  |
| 5580 | 1815.2.3 | CT4 aspects of Single Radio Video Call Continuity for 3G-CS | 134d? | 2011-06-03 A | 2011-12-02 A | 100% | 2011-06-03 | 2011-12-02 | 134d? | finish no earlier than 2011-12-02 | C4 | 1064h | 1064h | vSRVCC-CT | 27 | 29.280 | NEC | gottfried.punz@neclab.eu | Rel-11 | 52 | Kimmo |  |  |  |  |
| 5581 | 1816 | **Network-provided Location information for IMS (NETLOC)** | 720d? | 2010-06-10 A | 2013-03-01 A | 100% | 2010-06-10 | 2013-03-01 | 720d? |  | S2; S1; S5; C3; C4; C1 | 57274.7h | 57274.7h | NWK-PL2IMS | 25 |  | T-Mobile | michele.zarri@t-mobile.co.uk | Rel-11 | 48 | Maurice |  | NWK-PL2IMS |  |  |
| 5582 | 1816.1 | Stage 1 for Network-provided Location information for IMS | 203d? | 2010-12-15 A | 2011-09-21 A | 100% | 2010-12-15 | 2011-09-21 | 203d? | finish no earlier than 2011-09-21 | S1 | 1608h | 1608h | NWK-PL2IMS | 26 | 22.115 | n/a | n/a | Rel-11 | 50 | Alain |  |  |  |  |
| 5583 | 1816.2 | TR on Stage 2 for Network-provided Location information for IMS | 395d? | 2010-06-10 A | 2011-12-14 A | 100% | 2010-06-10 | 2011-12-14 | 395d? | finish no earlier than 2011-12-06 | S2 | 3160h | 3160h | NWK-PL2IMS | 25 | new 23.842 | T-Mobile | michele.zarri@t-mobile.co.uk | Rel-11 | 48 | Maurice |  |  |  |  |
| 5584 | 1816.3 | Stage 2 for Network-provided Location information for IMS | 455d? | 2010-06-15 A | 2012-03-07 A | 100% | 2010-06-15 | 2012-03-07 | 455d? | finish no earlier than 2012-03-07 | S2 | 3640h | 3640h | NWK-PL2IMS | 25 | 23.060; 23.203; 23.228; 23.401 | T-Mobile | michele.zarri@t-mobile.co.uk | Rel-11 | 48 | Maurice |  |  |  |  |
| 5585 | 1816.4 | Charging for Network-provided Location information for IMS | 515d? | 2010-09-23 A | 2012-09-12 A | 100% | 2010-09-23 | 2012-09-12 | 515d? | finish no earlier than 2012-09-12 | S5 | 4120h | 4120h | NWK-PL2IMS_CH | 25 | Stage 2 (32.240; 32.260); Stage 3 (32.298; 32.299) | Nokia Siemens Networks | Gerald.Goermer@nsn.com | Rel-11 | 49 | Mirko |  | NWK-PL2IMS_CH |  |  |

Notes:
- 5560: CP#57 completed
- 5561: CP#56 completed
- 5562: CP#57 completed
- 5563: CP#57 completed
- 5564: CP#55 completed
- 5565: SP#57 stopped. Updated WID SP-120419=>SP-120539 (removed BB3 objectives not implemented in Stage 2). SP#53 completed
- 5566: SP#57 updated WID SP-120419=>SP-120539 (removed BB3 objectives not implemented in Stage 2). SP#55 stopped
- 5567: CP#55 stopped
- 5568: CP#55 stopped
- 5569: CP#55 stopped
- 5570: CP#55 stopped
- 5571: CP#55 stopped
- 5572: SP#54 completed. Analyze and if needed specify mechanisms for the priority handling of SRVCC with regard to LTE/EPC
- 5573: SP#52 completed
- 5574: SP#54 completed
- 5575: CP#56 completed. Provide Single Radio VIDEO Call Continuity from E-UTRAN to UTRAN-CS based on the agreed architecture alternative in TR 23.886
- 5576: SP#53 completed. Triggered by Feasibility Study on video call handover capability in TR 23.886 UID_470048 Study on Single Radio Video Call Continuity for 3G-CS (FS_vSRVCC)
- 5577: Stage 3. CP#56 completed
- 5578: CP#56 completed
- 5579: CP#54 completed
- 5580: CP#54 completed
- 5581: Covers the case where UE is served by a 3GPP RAN. Architecture making Cell/PLMN ID (UE is camped on) available to IMS nodes when the operator needs to record this information either to fulfil legal obligations or for charging.
- 5582: SP#53 completed
- 5583: SP#54 completed
- 5584: SP#55 completed
- 5585: SP#57 completed

| ID | WBS | Task | Type | Duration | Start | Finish | Complete | Baseline start | Baseline finish | Baseline duration | Constraint | Resources | Work | Actual work | Acronym | PCG approved | WI rapporteur name | WI rapporteur e-mail | Release | TSG approved | MCC resp | Acronym_3GU_Export | Special Focus Doc | PCG stopped | TSG stopped |
| --- | --- | --- | --- | --- | --- | --- | --- | --- | --- | --- | --- | --- | --- | --- | --- | --- | --- | --- | --- | --- | --- | --- | --- | --- | --- |
| 5586 | 1816.5 | **CT aspects of Network-provided Location information for IMS (Stage 3)** |  | 266d? | 2012-03-02 A | 2013-03-01 A | 100% | 2012-03-02 | 2013-03-01 | 266d? |  | C3; C4; C1 | 10186.7h | 10186.7h | NWK-PL2IMS-CT | 28 | Huawei | Qiao Weihua (qiaoweihua@huawei.com) | Rel-11 | 55 | Adrian | NWK-PL2IMS_CT |  |  |  |
| 5587 | 1816.5.1 | CT3 part of CT aspects of Network-provided Location information for IMS |  | 138d? | 2012-03-02 A | 2012-09-07 A | 100% | 2012-03-02 | 2012-09-07 | 138d? | finish no earlier than 2012-09-07 | C3 | 1088h | 1088h | NWK-PL2IMS-CT | 28 | Huawei | Qiao Weihua (qiaoweihua@huawei.com) | Rel-11 | 55 | Adrian |  |  |  |  |
| 5588 | 1816.5.2 | CT4 part of CT aspects of Network-provided Location information for IMS |  | 77d? | 2012-03-02 A | 2012-06-15 A | 100% | 2012-03-02 | 2012-06-15 | 77d? | finish no earlier than 2012-06-01 | C4 | 608h | 608h | NWK-PL2IMS-CT | 28 | Huawei | Qiao Weihua (qiaoweihua@huawei.com) | Rel-11 | 55 | Kimmo |  |  |  |  |
| 5589 | 1816.5.3 | CT1 part of CT aspects of Network-provided Location information for IMS |  | 266d? | 2012-03-02 A | 2013-03-01 A | 100% | 2012-03-02 | 2013-03-01 | 266d? | finish no earlier than 2013-06-14 | C1 | 2106.67h | 2106.67h | NWK-PL2IMS-CT | 28 | Huawei | Qiao Weihua (qiaoweihua@huawei.com) | Rel-11 | 55 | Frederic |  |  |  |  |
| 5590 | 1817 | **Service Awareness and Privacy Policies** |  | 301.15d? | 2010-10-12 A | 2011-12-02 A | 100% | 2010-10-12 | 2011-12-02 | 301.15d? |  | S2; S1; C3 | 10667.6h | 10667.6h | SAPP | 26 | Allot | Alla Goldner (agoldner@allot.com) | Rel-11 | 50 | Maurice | SAPP |  |  |  |
| 5591 | 1817.1 | Stage 1 for Service Awareness and Privacy Policies |  | 46.15d? | 2010-10-12 A | 2010-12-15 A | 100% | 2010-10-12 | 2010-12-15 | 46.15d? | finish no earlier than 2010-12-15 | S1 | 369.2h | 369.2h | SAPP | 26 | Allot | Alla Goldner (agoldner@allot.com) | Rel-11 | 50 | Maurice |  |  |  |  |
| 5592 | 1817.2 | Stage 2 for Service Awareness and Privacy Policies |  | 199.85d? | 2010-10-15 A | 2011-09-21 A | 100% | 2010-10-15 | 2011-09-21 | 199.85d? | finish no earlier than 2011-09-21 | S2 | 1582.8h | 1582.8h | SAPP | 26 | Allot | Alla Goldner (agoldner@allot.com) | Rel-11 | 50 | Maurice |  |  |  |  |
| 5593 | 1817.3 | CT3 part of Service Awareness and Privacy Policies |  | 187d? | 2011-03-18 A | 2011-12-02 A | 100% | 2011-03-18 | 2011-12-02 | 187d? | finish no earlier than 2011-12-02 | C3 | 1488h | 1488h | SAPP-CT3 | 26 | Allot | Alla Goldner (agoldner@allot.com) | Rel-11 | 51 | Adrian | SAPP-CT3 |  |  |  |
| 5594 | 1818 | **VPLMN Autonomous CSG Roaming** |  | 307d? | 2010-10-15 A | 2011-12-14 A | 100% | 2010-10-15 | 2011-12-14 | 307d? |  | S2; C4 | 6974.61h | 6974.61h | VCSG | 26 | Qualcomm | AC Mahendran (ac@qualcomm.com) | Rel-11 | 50 | Maurice | VCSG |  |  |  |
| 5595 | 1818.1 | Stage 2 for VPLMN Autonomous CSG Roaming |  | 260.85d? | 2010-10-15 A | 2011-12-14 A | 100% | 2010-10-15 | 2011-12-14 | 260.85d? | finish no earlier than 2011-12-07 | S2 | 2062.61h | 2062.61h | VCSG | 26 | Qualcomm | AC Mahendran (ac@qualcomm.com) | Rel-11 | 50 | Maurice |  |  |  |  |
| 5596 | 1818.2 | CT aspects of VPLMN Autonomous CSG Roaming | milestone | 0d? | 2011-12-07 A | 2011-12-07 A | 100% | 2011-12-07 | 2011-12-07 | 0d? | finish no earlier than 2012-09-07 | C4 |  |  | VCSG-St3 | 27 | ZTE | Fei Lu (lu.fei1@zte.com.cn) | Rel-11 | 53 | Kimmo | VCSG-St3 |  |  |  |
| 5597 | 1819 | **Data Identification in Access Network Discovery and Selection Function (ANDSF)** |  | 455d? | 2011-03-23 A | 2012-12-07 A | 100% | 2011-03-23 | 2012-12-07 | 455d? |  | S2; C1 | 12488h | 12488h | DIDA | 26 | Qualcomm | Gerardo Giaretta (gerardo@qualcomm.com) | Rel-11 | 51 | Maurice | DIDA |  |  |  |
| 5598 | 1819.1 | TR on Stage 2 for Data Identification in ANDSF |  | 193d? | 2011-03-23 A | 2011-12-14 A | 100% | 2011-03-23 | 2011-12-14 | 193d? | finish no earlier than 2011-12-07 | S2 | 1544h | 1544h | DIDA | 26 | Qualcomm | Gerardo Giaretta (gerardo@qualcomm.com) | Rel-11 | 51 | Maurice |  |  |  |  |
| 5599 | 1819.2 | Stage 2 for Data Identification in ANDSF |  | 253d? | 2011-03-24 A | 2012-03-07 A | 100% | 2011-03-24 | 2012-03-07 | 253d? | finish no earlier than 2012-03-07 | S2 | 2024h | 2024h | DIDA | 26 | Qualcomm | Gerardo Giaretta (gerardo@qualcomm.com) | Rel-11 | 51 | Maurice |  |  |  |  |
| 5600 | 1819.3 | CT aspects of Data Identification in Access Network Discovery and Selection Function (ANDSF) Stage 3 |  | 205d? | 2012-03-02 A | 2012-12-07 A | 100% | 2012-03-02 | 2012-12-07 | 205d? | finish no earlier than 2012-12-07 | C1 | 1640h | 1640h | DIDA-CT | 28 | Qualcomm | Patrick Stupar (pstupar@qualcomm.com) | Rel-11 | 55 | Frederic | DIDA-CT |  |  |  |
| 5601 | 1820 | **LOcation-Based Selection of gaTEways foR WLAN** |  | 327d? | 2011-03-23 A | 2012-06-15 A | 100% | 2011-03-23 | 2012-06-15 | 327d? |  | S2; C4 | 10170.5h | 10170.5h | LOBSTER | 26 | ZTE | zhu.chunhui@zte.com.cn | Rel-11 | 51 | Maurice | LOBSTER | WLAN |  |  |
| 5602 | 1820.1 | Stage 2 for LOcation-Based Selection of gaTEways foR WLAN |  | 194d? | 2011-03-23 A | 2011-12-14 A | 100% | 2011-03-23 | 2011-12-14 | 194d? | finish no earlier than 2011-12-07 | S2 | 1546.52h | 1546.52h | LOBSTER | 26 | ZTE | zhu.chunhui@zte.com.cn | Rel-11 | 51 | Maurice |  | WLAN |  |  |
| 5603 | 1820.2 | **CT aspects of LOcation-Based Selection of gaTEways foR WLAN** |  | 142d? | 2011-12-02 A | 2012-06-15 A | 100% | 2011-12-02 | 2012-06-15 | 142d? |  | C4 | 3392h | 3392h | LOBSTER-CT | 28 | ZTE | zhou.xingyue@zte.com.cn | Rel-11 | 54 | Kimmo | LOBSTER-CT | WLAN |  |  |
| 5604 | 1820.2.1 | CT4 part of CT aspects of LOcation-Based Selection of gaTEways foR WLAN |  | 142d? | 2011-12-02 A | 2012-06-15 A | 100% | 2011-12-02 | 2012-06-15 | 142d? | finish no earlier than 2012-06-15 | C4 | 1128h | 1128h | LOBSTER-CT | 28 | ZTE | zhou.xingyue@zte.com.cn | Rel-11 | 54 | Kimmo |  | WLAN |  |  |
| 5605 | 1820.2.2 | Deleted - CT1 part of CT aspects of LOcation-Based Selection of gaTEways foR WLAN |  | 142d? | 2011-12-02 A | 2012-06-15 A | 100% | 2011-12-02 | 2012-06-15 | 142d? | finish no earlier than 2012-06-15 | C1 | 1128h | 1128h | LOBSTER-CT | 28 | ZTE | zhou.xingyue@zte.com.cn | Rel-11 | 54 | Frederic |  | WLAN | PCG-29 | CP-56 |
| 5606 | 1821 | **Single Radio Voice Call Continuity from UTRAN/GERAN to E-UTRAN/HSPA** |  | 929d? | 2011-09-12 A | 2015-03-13 A | 100% | 2011-09-12 | 2014-12-05 | 856d? |  | S2; C1; C3; C4; G2; R2; R3; R5 | 83776.8h | 83776.8h | rSRVCC | 27 | Orange | antoine.mouquet@orange-ftgroup.com | Rel-11 | 53 | Maurice | rSRVCC |  |  |  |
| 5607 | 1821.1 | Stage 2 for Single Radio Voice Call Continuity from UTRAN/GERAN to E-UTRAN/HSPA |  | 197d? | 2011-09-22 A | 2012-06-20 A | 100% | 2011-09-22 | 2012-06-20 | 197d? | finish no earlier than 2012-06-20 | S2 | 1568h | 1568h | rSRVCC | 27 | Orange | antoine.mouquet@orange-ftgroup.com | Rel-11 | 53 | Maurice |  |  |  |  |
| 5608 | 1821.2 | **CT aspects for Single Radio Voice Call Continuity from UTRAN/GERAN to E-UTRAN/HSPA (Stage 3)** |  | 259d? | 2011-09-16 A | 2012-09-07 A | 100% | 2011-09-16 | 2012-09-07 | 259d? |  | C1; C3; C4 | 12360h | 12360h | rSRVCC-CT | 27 | Ericsson | ivo.sedlacek@ericsson.com | Rel-11 | 53 | Frederic | rSRVCC-CT |  |  |  |
| 5609 | 1821.2.1 | CT1 part for Single Radio Voice Call Continuity from UTRAN/GERAN to E-UTRAN/HSPA |  | 258d? | 2011-09-16 A | 2012-09-07 A | 100% | 2011-09-16 | 2012-09-07 | 258d? | finish no earlier than 2012-09-07 | C1 | 2048h | 2048h | rSRVCC-CT | 27 | Ericsson | ivo.sedlacek@ericsson.com | Rel-11 | 53 | Frederic |  |  |  |  |
| 5610 | 1821.2.2 | CT3 part for Single Radio Voice Call Continuity from UTRAN/GERAN to E-UTRAN/HSPA |  | 257d? | 2011-09-19 A | 2012-09-07 A | 100% | 2011-09-19 | 2012-09-07 | 257d? | finish no earlier than 2012-09-07 | C3 | 2048h | 2048h | rSRVCC-CT | 27 | Ericsson | ivo.sedlacek@ericsson.com | Rel-11 | 53 | Adrian |  |  |  |  |
| 5611 | 1821.2.3 | CT4 part for Single Radio Voice Call Continuity from UTRAN/GERAN to E-UTRAN/HSPA |  | 257d? | 2011-09-19 A | 2012-09-07 A | 100% | 2011-09-19 | 2012-09-07 | 257d? | finish no earlier than 2012-09-07 | C4 | 2048h | 2048h | rSRVCC-CT | 27 | Ericsson | ivo.sedlacek@ericsson.com | Rel-11 | 53 | Kimmo |  |  |  |  |
| 5612 | 1821.3 | GERAN aspects of Single Radio Voice Call Continuity from UTRAN/GERAN to E-UTRAN/HSPA (Stage 3) |  | 476.1d? | 2011-09-12 A | 2013-06-28 A | 100% | 2011-09-12 | 2013-06-28 | 476.1d? | finish no earlier than 2013-11-22 | G2 | 2048h | 2048h | rSRVCC-GERAN | 27 | ZTE | li.jing4@zte.com.cn | Rel-11 | 51 | Gert | rSRVCC-GERAN |  |  |  |

Notes:
- 5586: Stage 3. 3/3: Acronym changed from "NWK-PL2IMS_CT"
- 5587: CP#57 completed. 3/3: Acronym changed from "NWK-PL2IMS_CT" / Impacted TSs and TRs: 29.212; 29.214; 29.215
- 5588: CP#57 completed. 3/3: Acronym changed from "NWK-PL2IMS_CT" / Impacted TSs and TRs: 23.008; 29.002; 29.060; 29.230; 29.272; 29.274; 29.305; 29.328; 29.329
- 5589: CP#57 completed. 3/3: Acronym changed from "NWK-PL2IMS_CT" / Impacted TSs and TRs: 24.229; 24.292
- 5590: CP#54 completed. Triggered by the SA1,SA2 Rel-10 TR 23.813 Study on Policy solutions and enhancements (FS_PP) UID_440047
- 5591: For deep packet inspection (i.e. Traffic Detection Functionality) SA1 indicated that no new requirements are needed (see Objective of FS_PP SA1,SA2 Rel-10 Study on Policy solutions and enhancements UID_440047 TR 23.813)
- 5592: SP#53 completed / Impacted TSs and TRs: 23.203
- 5593: CP#54 completed. Stage 3 to support Application Detection and Control Functionality. Update Gx / introduce Sd reference points and procedures. Update S9 reference point in roaming scenarios / Impacted TSs and TRs: 29.212; 29.213; 29.214; 29.215
- 5594: CP#56 completed. Linked to Rel-10 UID_450053 Enhanced Home NodeB / eNodeB (EHNB). Implements Rel-9 requirements for CSG support in SA1 TS 22.220
- 5595: SP#54 completed / Impacted TSs and TRs: 23.002; 23.060; 23.401
- 5596: CP#57 completed / Impacted TSs and TRs: 23.003; 23.007; 23.008; 23.012; 29.002; 29.230; 29.272
- 5597: SP#58 completed. Linked to Rel-10 IFOM (IP Flow Mobility and seamless WLAN offload) UID_450041. Defines IP flow mobility, seamless and non seamless WLAN offload and respective ANDSF extensions / Impacted TSs and TRs: Stage 2/3
- 5598: SP#54 completed / Impacted TSs and TRs: New 23.855
- 5599: SP#55 completed / Impacted TSs and TRs: 23.402
- 5600: CP#58 completed / Impacted TSs and TRs: 24.302; 24.312
- 5601: CP#56 completed. Related to UID_350027 SAE for support for non-3GPP accesses (SAES-SA-FP_n3GPP). Enhancements to ePDG and PDN GW selection functions for S2b and S2c based on UE location
- 5602: SP#54 completed / Impacted TSs and TRs: 23.402
- 5603: Stage 3. CP#56 completed / Impacted TSs and TRs: Stage 3
- 5604: CP#56 completed / Impacted TSs and TRs: 29.273
- 5605: CP#56 stopped / Impacted TSs and TRs: 24.302
- 5606: Stage 1 in Rel-8 TS 22.278 clause 7.1.4.2. Triggered by Rel-11 TR 23.885 Study on Single Radio Voice Call Continuity from UTRAN/GERAN to E-UTRAN/HSPA (FS_rSRVCC) UID_460030
- 5607: SP#56 completed / Impacted TSs and TRs: 23.216; 23.237
- 5608: CP#57 completed / Impacted TSs and TRs: Stage 3
- 5609: CP#57 completed / Impacted TSs and TRs: 23.009; 24.008; 24.229; 24.237; 24.292; 24.301
- 5610: CP#57 completed / Impacted TSs and TRs: 29.165; 29.292
- 5611: CP#57 completed / Impacted TSs and TRs: 23.003; 23.008; 29.002; 29.230; 29.272; 29.280; 29.303; 29.305; 29.328
- 5612: GP#60 completed. GP#51 approved WID / Impacted TSs and TRs: 44.018; 48.008

| ID | WBS | Task | Duration | Start | Finish | Complete | Baseline start | Baseline finish | Baseline duration | Constraint | Resources | Work | Actual work | Acronym | PCG approved | Impacted TSs and TRs | WI rapporteur name | Release | TSG approved | MCC resp | Acronym_3GU_Export | Status Report | Special Focus Doc | PCG stopped | TSG stopped |
| --- | --- | --- | --- | --- | --- | --- | --- | --- | --- | --- | --- | --- | --- | --- | --- | --- | --- | --- | --- | --- | --- | --- | --- | --- | --- |
| 5613 | 1821.4 | **UTRAN aspects of Single Radio Voice Call Continuity from UTRAN/GERAN to E-UTRAN/HSPA** | 325d? | 2011-09-19 A | 2012-12-07 A | 100% | 2011-09-19 | 2012-12-07 | 325d? |  | R3; R2 | 10400h | 10400h | rSRVCC-RAN_UTRA | 27 | UTRA | Huawei | Rel-11 | 53 | Juha | rSRVCC-RAN_UTRA |  |  |  |  |
| 5614 | 1821.4.1 | Core part: UTRAN aspects of Single Radio Voice Call Continuity from UTRAN/GERAN to E-UTRAN/HSPA | 325d? | 2011-09-19 A | 2012-12-07 A | 100% | 2011-09-19 | 2012-12-07 | 325d? | finish no earlier than 2012-12-07 | R3; R2 | 5200h | 5200h | rSRVCC-RAN_UTRA-Core | 27 | 25.331; 25.401; 25.413 | Huawei | Rel-11 | 53 | Juha | rSRVCC-RAN_UTRA-Core | RP-121553 |  |  |  |
| 5615 | 1821.5 | Test part: Single Radio Voice Call Continuity from UTRAN/GERAN to E-UTRAN/HSPA | 196d? | 2014-06-15 A | 2015-03-13 A | 100% | 2014-06-13 | 2014-12-05 | 126d? | finish no earlier than 2015-03-15 | R5 | 1568h | 1568h | rSRVCC-UEConTest | 33 | 36.508; 36.523-1; 36.523-2; 36.523-3 | Ericsson | Rel-11 | 64 |  | rSRVCC-UEConTest | RP-150133 |  |  |  |
| 5616 | 1822 | **S2a Mobility based On GTP and WLAN access to EPC** | 651d? | 2011-09-22 A | 2014-03-05 A | 100% | 2011-09-22 | 2014-03-05 | 651d? |  | S2; C4; C1; C3; IETF | 54000h | 54000h | SaMOG_WLAN | 27 | Stage 2/3 | ZTE | Rel-11 | 53 | Maurice | SaMOG_WLAN |  | WLAN |  |  |
| 5617 | 1822.1 | Stage 2 for S2a Mobility based On GTP and WLAN access to EPC | 121d? | 2011-09-22 A | 2012-03-07 A | 100% | 2011-09-22 | 2012-03-07 | 121d? | finish no earlier than 2012-03-07 | S2 | 968h | 968h | SaMOG_WLAN | 27 | 23.002; 23.203; 23.402 | ZTE | Rel-11 | 53 | Maurice |  |  | WLAN |  |  |
| 5618 | 1822.2 | **CN aspects of Mobility based On GTP & PMIPv6 for WLAN access to EPC** | 599d? | 2011-12-02 A | 2014-03-05 A | 100% | 2011-12-02 | 2014-03-05 | 599d? |  | C4; C1; C3; IETF | 26992h | 26992h | SaMOG_WLAN-CN | 28 | Stage 3 | Alcatel-Lucent | Rel-11 | 54 | Kimmo | SaMOG_WLAN-CN |  | WLAN |  |  |
| 5619 | 1822.2.1 | CT4 part of CN aspects of Mobility based On GTP & PMIPv6 for WLAN access to EPC | 203d? | 2011-12-02 A | 2012-09-07 A | 100% | 2011-12-02 | 2012-09-07 | 203d? | finish no earlier than 2012-09-07 | C4 | 1608h | 1608h | SaMOG_WLAN-CN | 28 | 23.003; 23.007; 23.008; 29.273; 29.274; 29.281; 29.303 | Alcatel-Lucent | Rel-11 | 54 | Kimmo |  |  | WLAN |  |  |
| 5620 | 1822.2.2 | Deleted - (IETF) CT4 part of CN aspects of Mobility based On GTP & PMIPv6 for WLAN access to EPC | 498d? | 2012-04-23 A | 2014-03-05 A | 100% | 2012-04-23 | 2014-03-05 | 498d? | finish no earlier than 2014-03-05 | C4-IETF | 3960h | 3960h | SaMOG_WLAN-CN | 29 | draft-ietf-radext-ieee802ext | Lionel Morand | Rel-11 | 56 | Kimmo |  |  | WLAN | PCG-32 | CP-53 |
| 5621 | 1822.2.3 | Deleted - CT1 part of CN aspects of Mobility based On GTP & PMIPv6 for WLAN access to EPC | 142d? | 2011-12-02 A | 2012-06-15 A | 100% | 2011-12-02 | 2012-06-15 | 142d? | finish no earlier than 2012-06-15 | C1 | 1128h | 1128h | SaMOG_WLAN-CN | 28 | 24.302 | Alcatel-Lucent | Rel-11 | 54 | Frederic |  |  | WLAN | PCG-29 | CP-56 |
| 5622 | 1822.2.4 | CT3 part of CN aspects of Mobility based On GTP & PMIPv6 for WLAN access to EPC | 142d? | 2011-12-02 A | 2012-06-15 A | 100% | 2011-12-02 | 2012-06-15 | 142d? | finish no earlier than 2012-09-07 | C3 | 1128h | 1128h | SaMOG_WLAN-CN | 28 | 29.212; 29.213; 29.215 | Alcatel-Lucent | Rel-11 | 54 | Adrian |  |  | WLAN |  |  |
| 5623 | 1823 | **Roaming Architecture for Voice over IMS with Local Breakout** | 273d? | 2011-11-28 A | 2012-12-07 A | 100% | 2011-11-28 | 2012-12-07 | 273d? |  | S2; S5; C1; C3 | 16904h | 16904h | RAVEL | 28 | Stage 2/3 | Deutsche Telekom | Rel-11 | 54 | Maurice | RAVEL |  |  |  |  |
| 5624 | 1823.1 | Stage 2 for Roaming Architecture for Voice over IMS with Local Breakout | 12d? | 2011-11-28 A | 2011-12-14 A | 100% | 2011-11-28 | 2011-12-14 | 12d? | finish no earlier than 2012-03-07 | S2 | 96h | 96h | RAVEL | 28 | 23.002; 23.228 | Deutsche Telekom | Rel-11 | 54 | Maurice |  |  |  |  |  |
| 5625 | 1823.2 | Charging for Roaming Architecture for Voice over IMS with Local Breakout | 196d? | 2011-12-14 A | 2012-09-12 A | 100% | 2011-12-14 | 2012-09-12 | 196d? | finish no earlier than 2012-09-12 | S5 | 1568h | 1568h | RAVEL-CH | 28 | 32.240; 32.260; 32.298; 32.299 | Nokia Siemens Networks | Rel-11 | 54 | Mirko | RAVEL-CH |  |  |  |  |
| 5626 | 1823.3 | **CT aspects of Roaming Architecture for Voice over IMS with Local Breakout (Stage 3)** | 205d? | 2012-03-02 A | 2012-12-07 A | 100% | 2012-03-02 | 2012-12-07 | 205d? |  | C1; C3 | 6504h | 6504h | RAVEL-CT | 28 | Stage 3 | Deutsche Telekom | Rel-11 | 55 | Frederic | RAVEL-CT |  |  |  |  |
| 5627 | 1823.3.1 | CT1 part of CT aspects of Roaming Architecture for Voice over IMS with Local Breakout | 204d? | 2012-03-02 A | 2012-12-07 A | 100% | 2012-03-02 | 2012-12-07 | 204d? | finish no earlier than 2012-12-07 | C1 | 1608h | 1608h | RAVEL-CT | 28 | 24.229; 24.292; 24.237 | Deutsche Telekom | Rel-11 | 55 | Frederic |  |  |  |  |  |
| 5628 | 1823.3.2 | CT3 part of CT aspects of Roaming Architecture for Voice over IMS with Local Breakout | 204d? | 2012-03-02 A | 2012-12-07 A | 100% | 2012-03-02 | 2012-12-07 | 204d? | finish no earlier than 2012-12-07 | C3 | 1616h | 1616h | RAVEL-CT | 28 | 29.165; 29.162; 29.079 | Deutsche Telekom | Rel-11 | 55 | Adrian |  |  |  |  |  |
| 5629 | 1824 | **IMS Overload Control** | 659d? | 2012-06-18 A | 2014-12-09 A | 100% | 2012-06-18 | 2014-12-05 | 654d? |  | S2; C1; C3; IETF | 52408h | 52408h | IOC | 29 | Stage 2/3 | Orange, China Mobile | Rel-11 | 56 | Maurice | IOC |  |  |  |  |
| 5630 | 1824.1 | Stage 2 for IMS Overload Control | 64d? | 2012-06-18 A | 2012-09-12 A | 100% | 2012-06-18 | 2012-09-12 | 64d? | finish no earlier than 2012-09-12 | S2 | 504h | 504h | IOC | 29 | 23.228 | Orange, China Mobile | Rel-11 | 56 | Maurice |  |  |  |  |  |
| 5631 | 1824.2 | **Stage 3 for IMS Overload Control** | 601d? | 2012-09-05 A | 2014-12-09 A | 100% | 2012-09-05 | 2014-12-05 | 596d? |  | C1; C3; IETF | 30816h | 30816h | IOC | 29 |  | Alcatel-Lucent | Rel-11 | 57 | Frederic |  |  |  |  |  |
| 5632 | 1824.2.1 | CT1 part of Stage 3 for IMS Overload Control | 70d? | 2012-09-05 A | 2012-12-07 A | 100% | 2012-09-05 | 2012-12-07 | 70d? | finish no earlier than 2012-12-07 | C1 | 544h | 544h | IOC | 29 | 24.229 | Alcatel-Lucent | Rel-11 | 57 | Frederic |  |  |  |  |  |
| 5633 | 1824.2.2 | CT3 part of Stage 3 for IMS Overload Control | 70d? | 2012-09-05 A | 2012-12-07 A | 100% | 2012-09-05 | 2012-12-07 | 70d? | finish no earlier than 2012-12-07 | C3 | 552h | 552h | IOC | 29 | 29.165 | Alcatel-Lucent | Rel-11 | 57 | Adrian |  |  |  |  |  |
| 5634 | 1824.2.3 | (IETF) CT part of Stage 3 for IMS Overload Control (soc-overload-control) | 361d? | 2013-07-29 A | 2014-12-09 A | 100% | 2013-07-29 | 2014-12-05 | 359d? | finish no earlier than 2014-12-09 | C1-IETF; C3-IETF | 5776h | 5776h | IOC | 29 | RFC 7339 | Keith Drage | Rel-11 | 57 | Frederic |  |  |  |  |  |
| 5635 | 1824.2.4 | (IETF) CT part of Stage 3 for IMS Overload Control (soc-overload-rate-control) | 361d? | 2013-07-29 A | 2014-12-09 A | 100% | 2013-07-29 | 2014-12-05 | 359d? | finish no earlier than 2014-12-09 | C1-IETF; C3-IETF | 5776h | 5776h | IOC | 29 | RFC 7415 | Keith Drage | Rel-11 | 57 | Frederic |  |  |  |  |  |
| 5636 | 1824.2.5 | (IETF) CT part of Stage 3 for IMS Overload Control (RFC 7200) | 234d? | 2013-07-29 A | 2014-06-13 A | 100% | 2013-07-29 | 2014-06-13 | 234d? | finish no earlier than 2014-06-13 | C1-IETF; C3-IETF | 3744h | 3744h | IOC | 29 | RFC 7200 (was draft-ietf-soc-load-control-event-package) | Keith Drage | Rel-11 | 57 | Frederic |  |  |  |  |  |
| 5637 | 1825 | Rel-11 Security small Enhancements | 336d? | 2011-06-08 A | 2012-09-12 A | 100% | 2011-06-08 | 2012-09-12 | 336d? | finish no earlier than 2012-09-12 | S3 | 2680h | 2680h | SEC11 | 27 |  |  | Rel-11 | 52 | Mirko | SEC11 |  |  |  |  |
| 5638 | 1826 | Lawful Interception in the 3GPP Rel-11 | 272d? | 2011-06-10 A | 2012-06-20 A | 100% | 2011-06-10 | 2012-06-20 | 272d? | finish no earlier than 2012-06-20 | S3 | 2176h | 2176h | LI11 | 27 | 33.106; 33.107; 33.108 | PIDS, Alcatel-Lucent | Rel-11 | 52 | Mirko | LI11 |  |  |  |  |

Notes:
- 5613: RP#58 completed / WI rapporteur e-mail: liwei.qiu@huawei.com
- 5614: RP#58 completed / WI rapporteur e-mail: liwei.qiu@huawei.com
- 5615: ¦Stat Rep: RP-141167->RP-141771 1st Apr 15: Compl:40%->100% 1st Apr 15: Stat Rep: RP-141771->RP-150133 / WI rapporteur e-mail: calle.hagenfeldt@ericsson.com
- 5616: Triggered by Rel-11 TR 23.852 FS_SaMOG UID_510061, Rel-8 UID_350027 SAE for support for non-3GPP accesses (defines PMIP-S2a) / WI rapporteur e-mail: Chunhui Zhu (zhu.chunhui@zte.com.cn)
- 5617: SP#55 completed / WI rapporteur e-mail: zhu.chunhui@zte.com.cn
- 5618: - / WI rapporteur e-mail: bruno.landais@alcatel-lucent.com
- 5619: CP#57 completed / WI rapporteur e-mail: bruno.landais@alcatel-lucent.com
- 5620: CP#63 Draft removed from 3GPP documentation
- 5621: CP#56 stopped (no CT1 impact) / WI rapporteur e-mail: bruno.landais@alcatel-lucent.com
- 5622: CP#56 completed / WI rapporteur e-mail: bruno.landais@alcatel-lucent.com
- 5623: CP#58 completed. Triggered by Rel-11 TR 23.850 Study on Roaming Architecture for Voice over IMS with Local Breakout (FS_RAVEL). GSMA CPWP LS_in S5-102806 asked 3GPP SA5 to check if CS voice charging principles also apply to voice over IMS / WI rapporteur e-mail: michele.zarri@telekom.com
- 5624: SP#54 completed / WI rapporteur e-mail: michele.zarri@telekom.com
- 5625: Stage 2/3. SP#57 completed / WI rapporteur e-mail: Gerald.Goermer@nsn.com
- 5626: CP#58 completed / WI rapporteur e-mail: reinhard.lauster@)t-mobile.at
- 5627: CP#58 completed / WI rapporteur e-mail: reinhard.lauster@)t-mobile.at
- 5628: CP#58 completed / WI rapporteur e-mail: reinhard.lauster@)t-mobile.at
- 5629: SP#57 Stage 2 completed. Moved Rel-12=>Rel-11 as CT finished Stage 3. Linked to UID_410041 Study on IMS Evolution (TR 23.812). Solutions from IETF SOC WG and existing 3GPP procedures to be re-used if possible & backward compatibility ensured / WI rapporteur e-mail: Antoine MOUQUET, YU Qing
- 5630: SP#57 completed. Moved Rel-12=>Rel-11 as CT finished Stage 3. / WI rapporteur e-mail: antoine.mouquet@orange-ftgroup.com, YU Qing
- 5631: - / WI rapporteur e-mail: Keith Drage
- 5632: CP#58 completed / WI rapporteur e-mail: Keith Drage
- 5633: CP#58 completed / WI rapporteur e-mail: Keith Drage
- 5634: in RFC Ed-queue. Dec.14: 75->100. Mar15: impacted spec updated (was draft-ietf-soc-overload-control). Jun 15: RFC 7339 (was draft-ietf-soc-overload-control) / WI rapporteur e-mail: Keith Drage
- 5635: Submitted to IESG for publication. Dec14: 50->90%. Mar15: 100%. Impacted RFC updated (was draft-ietf-soc-overload-rate-control). Jun 15: RFC 7415 (was draft-ietf-soc-overload-rate-control) / WI rapporteur e-mail: Keith Drage
- 5636: CP#64 completed / WI rapporteur e-mail: Keith Drage
- 5637: SEC11 is an umbrella Feature for Security related TEI11 type of changes that are not part of any other dedicated feature
- 5638: Stage 1/2/3. SP#56 completed / WI rapporteur e-mail: Koen Jaspers (k.b.jaspers@minjus.nl), terry.jacobson@alcatel-lucent.com

| ID | WBS | Task | Duration | Start | Finish | Complete | Baseline start | Baseline finish | Baseline duration | Constraint | Resources | Work | Actual work | Acronym | PCG approved | WI rapporteur name | Release | TSG approved | MCC resp | Acronym_3GU_Export | Status Report | Special Focus Doc |
| --- | --- | --- | --- | --- | --- | --- | --- | --- | --- | --- | --- | --- | --- | --- | --- | --- | --- | --- | --- | --- | --- | --- |
| 5639 | 1827 | **ZUC EEA3 and EIA3 (new Encryption & Integrity EPS security Algorithms)** | 857d? | 2009-06-04 A | 2012-09-07 A | 100% | 2009-06-04 | 2012-09-07 | 857d? |  | S3; R5 | 19488h | 19488h | EEA3_EIA3 | 23 | CATR | Rel-11 | 44 | Mirko | EEA3_EIA3 |  |  |
| 5640 | 1827.1 | ZUC EEA3 and EIA3 | 663d? | 2009-06-04 A | 2011-12-14 A | 100% | 2009-06-04 | 2011-12-14 | 663d? | finish no earlier than 2011-09-21 | S3 | 5288h | 5288h | EEA3_EIA3 | 23 | CATR | Rel-11 | 44 | Mirko |  |  |  |
| 5641 | 1827.2 | Conformance Test Aspects – ZUC (EEA3 and EIA3 Encryption & Integrity EPS security Algorithms) | 61d? | 2012-06-18 A | 2012-09-07 A | 100% | 2012-06-18 | 2012-09-07 | 61d? | finish no earlier than 2013-03-01 | R5 | 488h | 488h | EEA3_EIA3_UEConTest | 29 | CATR | Rel-11 | 56 | Ingbert | EEA3_EIA3_UEConTest | RP-120968 |  |
| 5642 | 1828 | Specification of Protection against Unsolicited Communication for IMS (produced TR-only) | 456d? | 2010-06-10 A | 2012-03-07 A | 100% | 2010-06-10 | 2012-03-07 | 456d? | finish no earlier than 2012-03-07 | S3 | 3640h | 3640h | SPUCI | 25 | NEC | Rel-11 | 48 | Mirko | SPUCI |  |  |
| 5643 | 1829 | H(e)NB security features for UE mobility scenarios (Stage 2) | 252d? | 2011-03-23 A | 2012-03-07 A | 100% | 2011-03-23 | 2012-03-07 | 252d? | finish no earlier than 2012-03-07 | S3 | 2008h | 2008h | HNB_mob_Sec | 26 | Huawei | Rel-11 | 51 | Mirko | HNB_mob_Sec |  | HNB |
| 5644 | 1830 | **Generic Bootstrapping Architecture (GBA) extensions for re-use of SIP Digest credentials** | 203d? | 2011-12-02 A | 2012-09-07 A | 100% | 2011-12-02 | 2012-09-07 | 203d? |  | S3; C4; C1 | 11824h | 11824h | GBA-ext | 28 | Nokia | Rel-11 | 54 | Mirko | GBA-ext |  |  |
| 5645 | 1830.1 | Stage 2 for GBA extensions for re-use of SIP Digest credentials | 61d? | 2011-12-14 A | 2012-03-07 A | 100% | 2011-12-14 | 2012-03-07 | 61d? | finish no earlier than 2012-02-28 | S3 | 488h | 488h | GBA-ext | 28 | Nokia | Rel-11 | 54 | Mirko |  |  |  |
| 5646 | 1830.2 | **Stage 3 for GBA extensions for re-use of SIP Digest credentials** | 203d? | 2011-12-02 A | 2012-09-07 A | 100% | 2011-12-02 | 2012-09-07 | 203d? |  | C4; C1 | 6464h | 6464h | GBA-ext-St3 | 28 | Alcatel-Lucent | Rel-11 | 54 | Kimmo | GBA-ext-St3 |  |  |
| 5647 | 1830.2.1 | CT4 part of Stage 3 for GBA extensions for re-use of SIP Digest credentials | 203d? | 2011-12-02 A | 2012-09-07 A | 100% | 2011-12-02 | 2012-09-07 | 203d? | finish no earlier than 2012-09-07 | C4 | 1608h | 1608h | GBA-ext-St3 | 28 | Alcatel-Lucent | Rel-11 | 54 | Kimmo |  |  |  |
| 5648 | 1830.2.2 | CT1 part of Stage 3 for GBA extensions for re-use of SIP Digest credentials | 202d? | 2011-12-05 A | 2012-09-07 A | 100% | 2011-12-05 | 2012-09-07 | 202d? | finish no earlier than 2012-09-07 | C1 | 1608h | 1608h | GBA-ext-St3 | 28 | Alcatel-Lucent | Rel-11 | 54 | Frederic |  |  |  |
| 5649 | 1831 | Extensions of Acoustic Test Specifications in TS 26.131 and TS 26.132 | 332d? | 2011-06-08 A | 2012-09-12 A | 100% | 2011-06-08 | 2012-09-12 | 332d? | finish no earlier than 2012-09-12 | S4 | 2648h | 2648h | Ext_ATS | 27 | Orange, Qualcomm | Rel-11 | 52 | Paolo | Ext_ATS |  |  |
| 5650 | 1832 | **Enhancements to Multimedia: PSS, MMS, and MBMS Enhancements and Performance Improvements** | 397d? | 2011-09-07 A | 2013-03-06 A | 100% | 2011-09-07 | 2013-03-06 | 397d? |  | S4 | 10928.6h | 10928.6h | EMM | 27 | Qualcomm | Rel-11 | 53 | Paolo | EMM |  |  |
| 5651 | 1832.1 | Enhancement to FEC for MBMS | 386d? | 2011-09-21 A | 2013-03-06 A | 100% | 2011-09-21 | 2013-03-06 | 386d? | finish no earlier than 2013-03-06 | S4 | 3048h | 3048h | EMM-EFEC | 27 | Qualcomm | Rel-11 | 53 | Paolo | EMM-EFEC |  |  |
| 5652 | 1832.2 | Download Delivery Enhancements for MBMS | 325d? | 2011-09-21 A | 2012-12-12 A | 100% | 2011-09-21 | 2012-12-12 | 325d? | finish no earlier than 2012-12-12 | S4 | 2576.59h | 2576.59h | EMM-DDE | 27 | Qualcomm | Rel-11 | 53 | Paolo | EMM-DDE |  |  |
| 5653 | 1832.3 | IMS-based PSS and MBMS Streaming Synchronization Enhancements | 268d? | 2011-09-07 A | 2012-09-12 A | 100% | 2011-09-07 | 2012-09-12 | 268d? | finish no earlier than 2012-09-12 | S4 | 2128h | 2128h | EMM-IPME | 27 | InterDigital Communications | Rel-11 | 53 | Paolo | EMM-IPME |  |  |
| 5654 | 1833 | Mobile 3D Video Coding | 71d? | 2012-06-07 A | 2012-09-12 A | 100% | 2012-06-07 | 2012-09-12 | 71d? | finish no earlier than 2012-09-12 | S4 | 560h | 560h | M3DV | 29 | Orange | Rel-11 | 56 | Paolo | M3DV |  |  |
| 5655 | 1834 | **Rel-11 Operations, Administration, Maintenance and Provisioning (OAM&P)** | 519d? | 2011-03-23 A | 2013-03-06 A | 100% | 2011-03-23 | 2013-03-06 | 519d? |  | S5 | 39394.5h | 39394.5h | OAM11 | 26 |  | Rel-11 | 51 | Mirko | OAM11 |  |  |
| 5656 | 1834.1 | **Rel-11 Network Infrastructure Management** | 519d? | 2011-03-23 A | 2013-03-06 A | 100% | 2011-03-23 | 2013-03-06 | 519d? |  | S5 | 8256h | 8256h | OAM11-NIM | 26 |  | Rel-11 | 51 | Mirko | OAM11-NIM |  |  |
| 5657 | 1834.1.1 | IRP framework enhancements to support Management of Converged Networks | 515d? | 2011-03-23 A | 2013-03-06 A | 100% | 2011-03-23 | 2013-03-06 | 515d? | finish no earlier than 2013-03-06 | S5 | 4104h | 4104h | OAM-FMC-IRP | 26 | Nokia Siemens Networks, Ericsson | Rel-11 | 51 | Mirko | OAM-FMC-IRP |  |  |
| 5658 | 1834.2 | **Rel-11 Performance Management** | 458d? | 2011-03-23 A | 2012-12-12 A | 100% | 2011-03-23 | 2012-12-12 | 458d? |  | S5 | 14530.5h | 14530.5h | OAM11-PM | 26 |  | Rel-11 | 51 | Mirko | OAM11-PM |  |  |
| 5659 | 1834.2.1 | IMS Performance Management enhancements | 252d? | 2011-03-23 A | 2012-03-07 A | 100% | 2011-03-23 | 2012-03-07 | 252d? | finish no earlier than 2012-09-12 | S5 | 2010.52h | 2010.52h | OAM-ePM-IMS | 26 | ZTE | Rel-11 | 51 | Mirko | OAM-ePM-IMS |  |  |
| 5660 | 1834.2.2 | Enhanced Management of UE based network performance measurements | 455d? | 2011-03-23 A | 2012-12-12 A | 100% | 2011-03-23 | 2012-12-12 | 455d? | finish no earlier than 2012-12-12 | S5 | 3624h | 3624h | OAM-ePM-UE | 26 | Huawei, Ericsson, Nokia Siemens Networks | Rel-11 | 51 | Mirko | OAM-ePM-UE |  |  |
| 5661 | 1834.2.3 | CN performance measurements enhancement | 334d? | 2011-06-08 A | 2012-09-12 A | 100% | 2011-06-08 | 2012-09-12 | 334d? | finish no earlier than 2012-09-12 | S5 | 2648h | 2648h | OAM-ePM-CN | 27 | China Mobile | Rel-11 | 52 | Mirko | OAM-ePM-CN |  |  |
| 5662 | 1834.2.4 | Management of Carrier Aggregation for LTE | 325d? | 2011-09-21 A | 2012-12-12 A | 100% | 2011-09-21 | 2012-12-12 | 325d? | finish no earlier than 2012-12-12 | S5 | 2584h | 2584h | OAM-CA | 27 | Nokia Siemens Networks, Ericsson | Rel-11 | 53 | Mirko | OAM-CA |  | CA |

Notes:
- 5639: RP#57 completed testing / WI rapporteur e-mail: Yuan Qi (yuanqi@catr.cn)
- 5640: SP#53 completed new EPS algorithms e.g. for China / Impacted TSs and TRs: 33.401; New (35.221; 35.222; 35.223; 35.924) / WI rapporteur e-mail: Yuan Qi (yuanqi@catr.cn)
- 5641: RP#57 completed. Testing for SA3 TSs 33.401, new (35.221, 35.222, 35.223) / Impacted TSs and TRs: 36.523-1; 36.523-2; 36.523-3 / WI rapporteur e-mail: Ms Jun Chen (chenjun@catr.cn)
- 5642: SP#55 completed (No normative work). TR 33.838v200 for Approval & abandoned new TS 33.237. Continuation of Rel-9 UID_410027/410029. Builds on TR 33.937 Study of Mechanisms for PUCI / Impacted TSs and TRs: New 33.838; abandoned New 33.237 / WI rapporteur e-mail: Anand R. Prasad (anand@bq.jp.nec.com)
- 5643: SP#55 completed. Add HeNB Security extensions to Extended H(e)NB Features (EHNBF) UID_450053 / Impacted TSs and TRs: 33.320 / WI rapporteur e-mail: Marcus Wong (mwong@huawei.com)
- 5644: Stage 2/3. CP#57 completed / WI rapporteur e-mail: Silke.Holtmanns@nokia.com
- 5645: SP#55 completed / Impacted TSs and TRs: 33.220 / WI rapporteur e-mail: Silke.Holtmanns@nokia.com
- 5646: CP#57 completed / Impacted TSs and TRs: Stage 3 / WI rapporteur e-mail: jean-jacques.trottin@alcatel-lucent.com
- 5647: CP#57 completed / Impacted TSs and TRs: 29.109 / WI rapporteur e-mail: jean-jacques.trottin@alcatel-lucent.com
- 5648: CP#57 completed / Impacted TSs and TRs: 24.109 / WI rapporteur e-mail: jean-jacques.trottin@alcatel-lucent.com
- 5649: SP#57 completed / Impacted TSs and TRs: 26.131; 26.132 / WI rapporteur e-mail: stephane.ragot@orange-ftgroup.com, Andre Schevciw (aschevci@qualcomm.com)
- 5650: Stage 3. SP#59 completed / Impacted TSs and TRs: 26.140; 26.234; 26.247; New 26.951=>26.851 / WI rapporteur e-mail: Nikolai Leung (nleung@qualcomm.com)
- 5651: SP#59 completed / Impacted TSs and TRs: 26.346; new 26.947 / WI rapporteur e-mail: Thomas Stockhammer (c_tstock@qualcomm.com)
- 5652: SP#58 completed / Impacted TSs and TRs: 26.346; new 26.951=>26.851 / WI rapporteur e-mail: Nikolai Leung (nleung@qualcomm.com)
- 5653: SP#58 completed / Impacted TSs and TRs: 26.237; new 26.951=>26.851 / WI rapporteur e-mail: hang.liu@interdigital.com
- 5654: SP#57 completed. Triggered by UID_520036 Rel-11 Study on Mobile 3D Video Coding (FS_M3DVC) TR 26.905. / Impacted TSs and TRs: 26.140; 26.234; 26.244; 26.245; 26.247; 26.346; 26.430; 26.905 / WI rapporteur e-mail: gilles.teniou@orange.com
- 5655: OAM11 is an umbrella Feature also for OAM&P related TEI11 type of changes that are not part of any other dedicated feature/WI
- 5656: -
- 5657: SP#59 completed. Triggered by SA5 Studies TR 32.833, 32.828, 32.831 / Impacted TSs and TRs: 32.101/103/150; new (28.620/621/622/623/624/625/626/627/628/629/631/632/633/651/652/653/654/655/656/657/658/659/661/662/663/671/672/673/674/675/676/701/702/703/704/705/706/707/708/709/731/732/733/734/735/736/751/752/753; 32.107/156/157/853/854 / WI rapporteur e-mail: thomas.tovinger@ericsson.com, olaf.pollakowski@nsn.com
- 5658: -
- 5659: SP#55 completed / Impacted TSs and TRs: 32.409 / WI rapporteur e-mail: guo.wenjie1@zte.com.cn
- 5660: SP#58 completed / Impacted TSs and TRs: 32.421; 32.422; 32.423; 32.441; 32.442; 32.446 / WI rapporteur e-mail: Zou Lan (zlan@huawei.com), ulf.hubinette@ericsson.com, gyula.bodog@nsn.com
- 5661: SP#57 completed / Impacted TSs and TRs: 32.406; 32.407; 32.426 / WI rapporteur e-mail: Liang Shuangchun (liangshuangchun@cmdi.chinamobile.com), Li Jian (lijian@chinamobile.com)
- 5662: SP#58 completed. Updated WID SP-110636=>SP-120776. Stage 2 in Rel-10 RAN Feature UID_460007 Carrier Aggregation for LTE (LTE_CA) / Impacted TSs and TRs: 32.425 / WI rapporteur e-mail: yizhi.yao@nsn.com, per.elmdahl@ericsson.com

| ID | WBS | Task | Type | Duration | Start | Finish | Complete | Baseline start | Baseline finish | Baseline duration | Constraint | Resources | Work | Actual work | Acronym | PCG approved | Release | TSG approved | MCC resp | Special Focus Doc | Acronym_3GU_Export | WI rapporteur name | WI rapporteur e-mail |
| --- | --- | --- | --- | --- | --- | --- | --- | --- | --- | --- | --- | --- | --- | --- | --- | --- | --- | --- | --- | --- | --- | --- | --- |
| 5663 | 1834.3 | **Rel-11 Self-Organizing Networks (SON) - OAM aspects** |  | 519d? | 2011-03-23 A | 2013-03-06 A | 100% | 2011-03-23 | 2013-03-06 | 519d? |  | S5 | 12456h | 12456h | OAM11-SON | 26 | Rel-11 | 51 | Mirko | SON | OAM11-SON |  |  |
| 5664 | 1834.3.1 | UTRAN Self-Organizing Networks (SON) management |  | 388d? | 2011-03-23 A | 2012-09-12 A | 100% | 2011-03-23 | 2012-09-12 | 388d? | finish no earlier than 2012-09-12 | S5 | 3088h | 3088h | OAM-SON-UTRAN | 26 | Rel-11 | 51 | Mirko | SON | OAM-SON-UTRAN | Huawei | kai.zhangkai@huawei.com |
| 5665 | 1834.3.2 | LTE Self-Organizing Networks (SON) coordination management |  | 387d? | 2011-09-21 A | 2013-03-06 A | 100% | 2011-09-21 | 2013-03-06 | 387d? | finish no earlier than 2013-03-06 | S5 | 3072h | 3072h | OAM-SON-LTE_COORD | 27 | Rel-11 | 53 | Mirko | SON | OAM-SON-LTE_COORD | Huawei, Nokia Siemens Networks | kai.zhangkai@huawei.com, clemens.suerbaum@nsn.com |
| 5666 | 1834.3.3 | Inter-RAT Energy Saving Management |  | 269d? | 2011-12-07 A | 2012-12-12 A | 100% | 2011-12-07 | 2012-12-12 | 269d? | finish no earlier than 2012-12-12 | S5 | 2144h | 2144h | OAM-IRAT-ESM | 28 | Rel-11 | 54 | Mirko | SON | OAM-IRAT-ESM | Nokia Siemens Networks, Huawei | clemens.suerbaum@nsn.com, xiahaitao@huawei.com |
| 5667 | 1835 | **Rel-11 Charging Management small Enhancements** |  | 717d? | 2010-03-25 A | 2012-12-12 A | 100% | 2010-03-25 | 2012-12-12 | 717d? |  | S5 | 11528h | 11528h | CH11 | 26 | Rel-11 | 51 | Mirko |  | CH11 |  |  |
| 5668 | 1835.1 | Add solutions for Rc - reference point within the Online Charging System (OCS) |  | 392d? | 2010-03-25 A | 2011-09-21 A | 100% | 2010-03-25 | 2011-09-21 | 392d? | finish no earlier than 2011-08-26 | S5 | 3120h | 3120h | CH-Rc | 24 | Rel-11 | 47 | Mirko |  | CH-Rc | Huawei | shan.mingjun@huawei.com |
| 5669 | 1835.2 | Charging for Policy Enhancements for Sponsored Connectivity and Coherent Access to Policy related Data Bases |  | 135d? | 2011-03-21 A | 2011-09-21 A | 100% | 2011-03-21 | 2011-09-21 | 135d? | finish no earlier than 2011-09-21 | S5 | 1064h | 1064h | PEST-CH | 26 | Rel-11 | 51 | Mirko |  | PEST-CH | Ericsson | patrik.teppo@@ericsson.com |
| 5670 | 1835.3 | Unification of Charging session from SIP AS and SRVCC functions in IMS |  | 203d? | 2012-03-07 A | 2012-12-12 A | 100% | 2012-03-07 | 2012-12-12 | 203d? | finish no earlier than 2012-12-12 | S5 | 1608h | 1608h | UCHIMS_AS-SRVCC | 28 | Rel-11 | 55 | Mirko |  | UCHIMS_AS-SRVCC | Alcatel-Lucent | maryse.gardella@alcatel-lucent.com |
| 5671 | 1836 | **Transit Inter Operator Identifier for IMS Interconnection Charging in multi operator environment** |  | 432d? | 2010-10-27 A | 2012-06-15 A | 100% | 2010-10-27 | 2012-06-15 | 432d? |  | S5; S1; C1 | 15921.1h | 15921.1h | IOI_IMS_CH | 26 | Rel-11 | 51 | Mirko |  | IOI_IMS_CH | Deutsche Telekom | matthias.seibel@telekom.de |
| 5672 | 1836.1 | Stage 1 for Transit Inter Operator Identifier for IMS Interconnection Charging in multi operator environment |  | 237d? | 2010-10-27 A | 2011-09-21 A | 100% | 2010-10-27 | 2011-09-21 | 237d? |  | S1 | 1896h | 1896h | IOI_IMS_CH | 26 | Rel-11 | 51 | Dionisio |  |  | Deutsche Telekom | matthias.seibel@telekom.de |
| 5673 | 1836.2 | Stage 2/3 SA5 part of Transit Inter Operator Identifier for IMS Interconnection Charging in multi operator environment |  | 187d? | 2010-10-27 A | 2011-12-07 A | 100% | 2010-10-27 | 2011-12-07 | 187d? | finish no earlier than 2012-03-21 | S5 | 1488h | 1488h | IOI_IMS_CH | 26 | Rel-11 | 51 | Mirko |  |  | Deutsche Telekom | matthias.seibel@telekom.de |
| 5674 | 1836.3 | Stage 3 for Transit Inter Operator Identifier for IMS Interconnection Charging in multi operator environment |  | 273d? | 2011-06-07 A | 2012-06-15 A | 100% | 2011-06-07 | 2012-06-15 | 273d? | finish no earlier than 2012-06-01 | C1 | 2169.09h | 2169.09h | IOI_IMS_CH | 27 | Rel-11 | 52 | Frederic |  |  | Deutsche Telekom | martin.huelsemann@telekom.de] |
| 5675 | 1837 | **User Data Convergence - Data Model** |  | 647d? | 2010-03-25 A | 2012-09-07 A | 100% | 2010-03-25 | 2012-09-07 | 647d? |  | C4; S1 | 22984h | 22984h | UDC_DM | 25 | Rel-11 | 48 | Kimmo |  | UDC_DM | Telecom Italia | mauro.ficaccio@telecomitalia.it |
| 5676 | 1837.1 | Stage 1 for UDC Data Model |  | 392d? | 2010-03-25 A | 2011-09-21 A | 100% | 2010-03-25 | 2011-09-21 | 392d? | finish no earlier than 2010-06-10 | S1 | 3136h | 3136h | UDC_DM | 25 | Rel-11 | 48 | Alain |  |  | Telecom Italia | mauro.ficaccio@telecomitalia.it |
| 5677 | 1837.2 | TR on User Data Convergence (UDC) Data Model |  | 593d? | 2010-06-04 A | 2012-09-07 A | 100% | 2010-06-04 | 2012-09-07 | 593d? | finish no earlier than 2012-09-07 | C4 | 4736h | 4736h | UDC_DM | 25 | Rel-11 | 48 | Kimmo |  |  | Telecom Italia | mauro.ficaccio@telecomitalia.it |
| 5678 | 1837.3 | User Data Convergence (UDC) Data Model |  | 596d? | 2010-06-04 A | 2012-09-07 A | 100% | 2010-06-04 | 2012-09-07 | 596d? | finish no earlier than 2012-09-07 | C4 | 4760h | 4760h | UDC_DM | 25 | Rel-11 | 48 | Kimmo |  |  | Telecom Italia | mauro.ficaccio@telecomitalia.it |
| 5679 | 1838 | Definition of the UICC Application for Hosting Party Module |  | 327d? | 2011-03-18 A | 2012-06-15 A | 100% | 2011-03-18 | 2012-06-15 | 327d? | finish no earlier than 2012-06-15 | C6 | 2608h | 2608h | HPM_UICC | 26 | Rel-11 | 51 | Xavier |  | HPM_UICC | Gemalto | Denis.Lheriteau@gemalto.com |
| 5680 | 1839 | Usability improvement of Inter-IMS Network to Network Interface (II-NNI) specification for inter-connection by means of Option Item list |  | 273d? | 2011-06-07 A | 2012-06-15 A | 100% | 2011-06-07 | 2012-06-15 | 273d? | finish no earlier than 2012-06-01 | C3 | 2169.56h | 2169.56h | NNI_OI | 27 | Rel-11 | 52 | Adrian |  | NNI_OI | NTT | arai.kenjiro@lab.ntt.co.jp |
| 5681 | 1840 | **enhanced Nodes Restoration for EPC (Stage 2/3)** |  | 668d? | 2011-06-03 A | 2013-12-06 A | 100% | 2011-06-03 | 2013-12-06 | 668d? |  | C4; C1; C3; IETF | 27728h | 27728h | eNR_EPC | 27 | Rel-11 | 52 | Kimmo |  | eNR_EPC | ZTE | lu.fei1@zte.com.cn |
| 5682 | 1840.1 | CT4 part of enhanced Nodes Restoration for EPC |  | 402d? | 2011-06-03 A | 2012-12-07 A | 100% | 2011-06-03 | 2012-12-07 | 402d? | finish no earlier than 2012-12-07 | C4 | 3192h | 3192h | eNR_EPC | 27 | Rel-11 | 52 | Kimmo |  |  | ZTE | lu.fei1@zte.com.cn |
| 5683 | 1840.2 | (IETF) CT4 part of enhanced Nodes Restoration for EPC (RFC 7077) |  | 266d? | 2012-12-07 A | 2013-12-06 A | 100% | 2012-12-07 | 2013-12-06 | 266d? | finish no earlier than 2013-12-06 | C4-IETF | 2104h | 2104h | eNR_EPC | 30 | Rel-11 | 58 | Kimmo |  |  | Lionel Morand | Lionel Morand |
| 5684 | 1840.3 | CT1 part of enhanced Nodes Restoration for EPC |  | 66d? | 2011-12-02 A | 2012-03-02 A | 100% | 2011-12-02 | 2012-03-02 | 66d? | finish no earlier than 2012-06-15 | C1 | 528h | 528h | eNR_EPC | 28 | Rel-11 | 54 | Frederic |  |  | ZTE | lu.fei1@zte.com.cn |
| 5685 | 1840.4 | CT3 part of enhanced Nodes Restoration for EPC |  | 67d? | 2012-09-10 A | 2012-12-07 A | 100% | 2012-09-10 | 2012-12-07 | 67d? | finish no earlier than 2012-12-07 | C3 | 528h | 528h | eNR_EPC | 29 | Rel-11 | 57 | Adrian |  |  | ZTE | lu.fei1@zte.com.cn |
| 5686 | 1841 | **Reference Location Information (Stage 3)** |  | 78d? | 2011-06-03 A | 2011-09-16 A | 100% | 2011-06-03 | 2011-09-16 | 78d? |  | C4; C1 | 1860.74h | 1860.74h | RLI | 27 | Rel-11 | 52 | Kimmo |  | RLI | Huawei | susan.shishufeng@Huawei.com |
| 5687 | 1841.1 | CT4 part of Reference Location Information (Stage 3) | milestone | 0d? | 2011-06-03 A | 2011-06-03 A | 100% | 2011-06-03 | 2011-06-03 | 0d? | finish no earlier than 2011-06-03 | C4 |  |  | RLI | 27 | Rel-11 | 52 | Kimmo |  |  | Huawei | susan.shishufeng@Huawei.com |
| 5688 | 1841.2 | CT1 part of Reference Location Information (Stage 3) |  | 78d? | 2011-06-03 A | 2011-09-16 A | 100% | 2011-06-03 | 2011-09-16 | 78d? | finish no earlier than 2011-08-30 | C1 | 612.74h | 612.74h | RLI | 27 | Rel-11 | 52 | Frederic |  |  | Huawei | susan.shishufeng@Huawei.com |

Notes:
- 5663: -
- 5664: SP#57 completed. Updated WID SP-110518=>SP-120552 / Impacted TSs and TRs: UTRA 32.405; 32.500; 32.511; 32.521; 32.522; 32.526; 32.642; 32.646
- 5665: SP#59 completed / Impacted TSs and TRs: LTE 32.425; 32.500; 32.521; 32.522; 32.526; 32.762; 32.766
- 5666: SP#58 completed. Triggered by Rel-11 TR 32.834 (Study on OAM aspects of inter-RAT Energy Saving) UID_510045. Needs coordination with RAN WGs / Impacted TSs and TRs: 32.405; 32.551; 32.522; 32.526; 32.642; 32.646; 32.762; 32.766
- 5667: CH11 is an umbrella Feature also for OAM&P related TEI11 type of changes that are not part of any other dedicated feature/WI / Impacted TSs and TRs: 30.821
- 5668: SP#53 completed. Stage 3 (Stage 1 in 22.115). Triggered by Rel-10 TR 32.825 SA5 Study on Rc Reference Point Functionalities and Message Flows (UID_410044) / Impacted TSs and TRs: 32.296; 32.299
- 5669: SP#53 completed. Stage 3 / Impacted TSs and TRs: 32.251; 32.298; 32.299
- 5670: Stage 2/3. SP#58 completed / Impacted TSs and TRs: 32.260; 32.275; 32.298; 32.299
- 5671: Stage 2/3. CP#56 completed. Stage 1 in SA1 22.115
- 5672: SP#53 completed under IPXS / Impacted TSs and TRs: 22.115
- 5673: SP#54 completed / Impacted TSs and TRs: 32.240; 32.260; 32.298; 32.299
- 5674: CP#56 completed / Impacted TSs and TRs: 24.229
- 5675: CP#57 completed. SP#48 Stage 1 completed as Rel-10
- 5676: SP#53 completed under Rel-10 UDC / Impacted TSs and TRs: 22.101
- 5677: CP#57 completed / Impacted TSs and TRs: new 29.935
- 5678: CP#57 completed / Impacted TSs and TRs: 29.335
- 5679: CP#56 completed / Impacted TSs and TRs: 31.102; New 31.104
- 5680: CP#56 completed. Stage 3 (No architectural change, specify the list of selectable items related to control plane signalling directly for the same architecture) / Impacted TSs and TRs: 29.165
- 5681: Triggered by DRAFT TR 23.857 Study on EPC Nodes Restoration UID_490014
- 5682: CP#58 completed / Impacted TSs and TRs: 23.007; 23.008; 23.018; 29.274; 29.275
- 5683: CP#62 completed / Impacted TSs and TRs: RFC 7077 (was draft-ietf-netext-update-notifications)
- 5684: CP#55 completed / Impacted TSs and TRs: 29.118
- 5685: CP#58 completed / Impacted TSs and TRs: 29.212
- 5686: CP#53 completed. Stage 2 clause C.1.1 of SA2 TS 23.167 CR#0182 (WI code: TEI11)
- 5687: CP#52 completed / Impacted TSs and TRs: 23.008; 29.228; 29.328; 29.329
- 5688: CP#53 completed / Impacted TSs and TRs: 24.229

| ID | WBS | Task | Duration | Start | Finish | Complete | Baseline start | Baseline finish | Baseline duration | Constraint | Resources | Work | Actual work | Acronym | PCG approved | WI rapporteur name | WI rapporteur e-mail | Release | TSG approved | MCC resp | Acronym_3GU_Export | PCG stopped | TSG stopped | Special Focus Doc |
| --- | --- | --- | --- | --- | --- | --- | --- | --- | --- | --- | --- | --- | --- | --- | --- | --- | --- | --- | --- | --- | --- | --- | --- | --- |
| 5689 | 1842 | **IMS Stage 3 IETF Protocol Alignment - phase 5** | 868d? | 2011-06-07 A | 2014-09-12 A | 100% | 2011-06-07 | 2014-12-05 | 927d? |  | C1; C3; IETF | 37516h | 37516h | IMSProtoc5 | 27 | Alcatel-Lucent | keith.drage@alcatel-lucent.com | Rel-11 | 52 | Frederic | IMSProtoc5 |  |  |  |
| 5690 | 1842.1 | CT1 part of IMS Stage 3 IETF Protocol Alignment - phase 5 | 333d? | 2011-06-07 A | 2012-09-07 A | 100% | 2011-06-07 | 2012-09-07 | 333d? | finish no earlier than 2012-09-07 | C1 | 2648h | 2648h | IMSProtoc5 | 27 | Alcatel-Lucent | keith.drage@alcatel-lucent.com | Rel-11 | 52 | Frederic |  |  |  |  |
| 5691 | 1842.2 | (IETF) CT1 part of IMS Stage 3 IETF Protocol Alignment - phase 5 (RFC 7315) | 356.5d? | 2013-03-01 A | 2014-09-12 A | 100% | 2013-03-01 | 2014-12-05 | 416.5d? | finish no earlier than 2014-09-12 | C1-IETF | 2812h | 2812h | IMSProtoc5 | 30 | Roland Jesske | Roland Jesske | Rel-11 | 59 | Frederic |  |  |  |  |
| 5692 | 1842.3 | (IETF) A P-Served-User Header Field Parameter for Originating CDIV session case in SIP (draft-ietf-sipcore-originating-cdiv-parameter) --> RFC 8498 | 407d? | 2013-03-01 A | 2014-09-12 A | 100% |  |  |  | finish no earlier than 2014-09-12 | C1-IETF | 3256h | 3256h | IMSProtoc5 | 41 | Roland Jesske | Roland Jesske | Rel-11 | 80 |  |  |  |  |  |
| 5693 | 1842.4 | (IETF) CT1 part of IMS Stage 3 IETF Protocol Alignment - phase 5 (RFC 7135) | 203d? | 2013-09-06 A | 2014-06-13 A | 100% | 2013-09-06 | 2014-06-13 | 203d? | finish no earlier than 2014-06-13 | C1-IETF | 1608h | 1608h | IMSProtoc5 | 31 | Roland Jesske | Roland Jesske | Rel-11 | 61 |  |  |  |  |  |
| 5694 | 1842.5 | CT3 part of IMS Stage 3 IETF Protocol Alignment - phase 5 | 333d? | 2011-06-07 A | 2012-09-07 A | 100% | 2011-06-07 | 2012-09-07 | 333d? | finish no earlier than 2012-09-07 | C3 | 2648h | 2648h | IMSProtoc5 | 27 | Alcatel-Lucent | keith.drage@alcatel-lucent.com | Rel-11 | 52 | Adrian |  |  |  |  |
| 5695 | 1842.6 | Deleted - (IETF) CT3 part of IMS Stage 3 IETF Protocol Alignment - phase 5 (avasarala-dispatch-comm-div-notification) | 466d? | 2012-12-07 A | 2014-09-12 A | 100% | 2012-12-07 | 2014-12-05 | 526d? | finish no earlier than 2014-09-12 | C3-IETF | 3712h | 3712h | IMSProtoc5 | 30 | Andrew Allen | Andrew Allen | Rel-11 | 58 | Adrian |  | PCG-33 | CP-65 |  |
| 5696 | 1843 | **Service Identification for RRC Improvements in GERAN (Stage 2/3)** | 258d? | 2011-09-19 A | 2012-09-07 A | 100% | 2011-09-19 | 2012-09-07 | 258d? |  | S2; C4; C3; G2 | 16216h | 16216h | SIRIG | 27 | China Mobile | zhanghao@chinamobile.com | Rel-11 | 51 | Maurice | SIRIG |  |  |  |
| 5697 | 1843.1 | Stage 2 for Service Identification for RRC Improvements in GERAN | 61d? | 2012-06-18 A | 2012-09-07 A | 100% | 2012-06-18 | 2012-09-07 | 61d? | finish no earlier than 2012-09-07 | S2 | 480h | 480h | SIRIG | 29 |  |  | Rel-11 | 56 | Maurice |  |  |  |  |
| 5698 | 1843.2 | **CN aspects of Service Identification for RRC Improvements in GERAN** | 203d? | 2011-12-02 A | 2012-09-07 A | 100% | 2011-12-02 | 2012-09-07 | 203d? |  | C4; C3 | 5464h | 5464h | SIRIG | 28 | China Mobile | zhanghao@chinamobile.com | Rel-11 | 54 | Kimmo |  |  |  |  |
| 5699 | 1843.2.1 | CT4 part of CN aspects of Service Identification for RRC Improvements in GERAN | 203d? | 2011-12-02 A | 2012-09-07 A | 100% | 2011-12-02 | 2012-09-07 | 203d? | finish no earlier than 2012-09-07 | C4 | 1608h | 1608h | SIRIG | 28 | China Mobile | zhanghao@chinamobile.com | Rel-11 | 54 | Kimmo |  |  |  |  |
| 5700 | 1843.2.2 | Deleted - CT3 part of CN aspects of Service Identification for RRC Improvements in GERAN | 77d? | 2012-03-02 A | 2012-06-15 A | 100% | 2012-03-02 | 2012-06-15 | 77d? | finish no earlier than 2012-06-01 | C3 | 608h | 608h | SIRIG | 28 | China Mobile | zhanghao@chinamobile.com | Rel-11 | 55 | Adrian |  | PCG-29 | CP-56 |  |
| 5701 | 1843.3 | GERAN2 part of Service Identification for RRC Improvements in GERAN | 252d? | 2011-09-19 A | 2012-08-31 A | 100% | 2011-09-19 | 2012-08-31 | 252d? | finish no earlier than 2012-08-31 | G2 | 2016h | 2016h | SIRIG | 27 | China Mobile, Huawei | Juan Deng, Yang Zhao | Rel-11 | 51 | Gert |  |  |  |  |
| 5702 | 1844 | **SAE Protocol Development - Phase 2** | 259d? | 2011-09-16 A | 2012-09-07 A | 100% | 2011-09-16 | 2012-09-07 | 259d? |  | C1 | 6168h | 6168h | SAES2 | 27 | Nokia Siemens Networks | robert.zaus@nsn.com | Rel-11 | 53 | Frederic | SAES2 |  |  |  |
| 5703 | 1844.1 | SAE Protocol Development (Stage 3) - Phase 2 | 259d? | 2011-09-16 A | 2012-09-07 A | 100% | 2011-09-16 | 2012-09-07 | 259d? | finish no earlier than 2012-09-07 | C1 | 2048h | 2048h | SAES2 | 27 | Nokia Siemens Networks | robert.zaus@nsn.com | Rel-11 | 53 | Frederic |  |  |  |  |
| 5704 | 1844.2 | CS Fallback in EPS - Phase 2 | 259d? | 2011-09-16 A | 2012-09-07 A | 100% | 2011-09-16 | 2012-09-07 | 259d? | finish no earlier than 2012-09-07 | C1 | 2048h | 2048h | SAES2-CSFB | 27 | Nokia Siemens Networks | robert.zaus@nsn.com | Rel-11 | 53 | Frederic | SAES2-CSFB |  |  |  |
| 5705 | 1845 | **GCSMSC and GCR Redundancy for VGCS/VBS (Stage 2/3)** | 258d? | 2011-09-19 A | 2012-09-07 A | 100% | 2011-09-19 | 2012-09-07 | 258d? |  | C1 | 5680h | 5680h | RT_VGCS_Red | 27 | Nokia Siemens Networks | robert.zaus@nsn.com | Rel-11 | 53 | Frederic | RT_VGCS_Red |  |  |  |
| 5706 | 1845.1 | CT1 part of GCSMSC and GCR Redundancy for VGCS/VBS | 258d? | 2011-09-19 A | 2012-09-07 A | 100% | 2011-09-19 | 2012-09-07 | 258d? | finish no earlier than 2012-09-07 | C1 | 2048h | 2048h | RT_VGCS_Red | 27 | Nokia Siemens Networks | robert.zaus@nsn.com | Rel-11 | 53 | Frederic |  |  |  |  |
| 5707 | 1845.2 | Deleted - CT4 part of GCSMSC and GCR Redundancy for VGCS/VBS | 197d? | 2011-09-19 A | 2012-06-15 A | 100% | 2011-09-19 | 2012-06-15 | 197d? | finish no earlier than 2012-06-15 | C4 | 1568h | 1568h | RT_VGCS_Red | 27 | Nokia Siemens Networks | robert.zaus@nsn.com | Rel-11 | 53 | Kimmo |  | PCG-29 | CP-56 |  |
| 5708 | 1846 | Support of RFC 6140 in IMS | 203d? | 2011-12-02 A | 2012-09-07 A | 100% | 2011-12-02 | 2012-09-07 | 203d? | finish no earlier than 2012-09-07 | C1 | 1608h | 1608h | GINI | 28 | Deutsche Telekom | martin.huelsemann@telekom.de | Rel-11 | 54 | Frederic | GINI |  |  |  |
| 5709 | 1847 | **Enhancements for Multimedia Priority Service (MPS) – Gateway Control Priority** | 203d? | 2011-12-02 A | 2012-09-07 A | 100% | 2011-12-02 | 2012-09-07 | 203d? |  | C4; C3 | 6464h | 6464h | eMPS_Gateway | 28 | Telcordia | Viqar Shaikh | Rel-11 | 54 | Kimmo | eMPS_Gateway |  |  | Public Safety (I-A) |
| 5710 | 1847.1 | CT4 part of Enhancements for Multimedia Priority Service (MPS) – Gateway Control Priority | 202d? | 2011-12-02 A | 2012-09-07 A | 100% | 2011-12-02 | 2012-09-07 | 202d? | finish no earlier than 2012-09-07 | C4 | 1608h | 1608h | eMPS_Gateway | 28 | Telcordia | Viqar Shaikh | Rel-11 | 54 | Kimmo |  |  |  | Public Safety (I-A) |
| 5711 | 1847.2 | CT3 part of Enhancements for Multimedia Priority Service (MPS) – Gateway Control Priority | 202d? | 2011-12-02 A | 2012-09-07 A | 100% | 2011-12-02 | 2012-09-07 | 202d? | finish no earlier than 2012-09-07 | C3 | 1608h | 1608h | eMPS_Gateway | 28 | Telcordia | Viqar Shaikh | Rel-11 | 54 | Adrian |  |  |  | Public Safety (I-A) |
| 5712 | 1848 | Inter-IMS Network to Network Interface (II-NNI) enhancements: SIP timers applicability (Stage 3) | 138d? | 2012-03-02 A | 2012-09-07 A | 100% | 2012-03-02 | 2012-09-07 | 138d? | start no earlier than 2012-03-02 | C3 | 1088h | 1088h | NNI_timers | 28 | Telecom Italia | antonio.ascolese@telecomitalia.it | Rel-11 | 55 | Adrian | NNI_timers |  |  |  |
| 5713 | 1849 | AT commands for Universal Resource Identifier (URI) support | 188d? | 2012-06-15 A | 2013-03-01 A | 100% | 2012-06-15 | 2013-03-01 | 188d? | finish no earlier than 2013-03-01 | C1 | 1496h | 1496h | ATURI | 29 | Intel | frank.kowalewski@intel.com | Rel-11 | 56 | Frederic | ATURI |  |  |  |
| 5714 | 1850 | PS Additional Number (Stage 3) | 62d? | 2012-06-15 A | 2012-09-07 A | 100% | 2012-06-15 | 2012-09-07 | 62d? | finish no earlier than 2012-09-07 | C4 | 488h | 488h | PSAN | 29 | Deutsche Telekom | Yvette.koza@t-mobile.at | Rel-11 | 56 | Kimmo | PSAN |  |  |  |
| 5715 | 1851 | Generic IMS User Group Over Sh | 62d? | 2012-06-15 A | 2012-09-07 A | 100% | 2012-06-15 | 2012-09-07 | 62d? | finish no earlier than 2012-09-07 | C4 | 488h | 488h | GenUG_Sh | 29 | Alcatel-Lucent | jean-jacques.trottin@alcatel-lucent.com | Rel-11 | 56 | Kimmo | GenUG_Sh |  |  |  |

Notes:
- 5689: CP#57 completed
- 5690: CP#57 completed / Impacted TSs and TRs: 23.218; 24.229; 24.930
- 5691: CP#65 completed / Impacted TSs and TRs: RFC 7315 (was draft-drage-sipping-rfc3455bis); draft-mohali-dispatch-originating-cdiv-parameter
- 5692: 26/6/19: 25%->100; 23/4/20: 100%->100
- 5693: CP#64 completed / Impacted TSs and TRs: RFC 7135 (was draft-polk-local-emergency-rph-namespace)
- 5694: CP#57 completed / Impacted TSs and TRs: 29.163; 29.165
- 5695: CP#64 Draft removed from 3GPP documentation / Impacted TSs and TRs: draft-avasarala-dispatch-comm-div-notification
- 5696: TSG#57, GP#55 completed. CT defined a generic solution (not only for GERAN) / Impacted TSs and TRs: GERAN
- 5697: SP#57 completed / Impacted TSs and TRs: 23.060; 23.251
- 5698: CP#57 completed
- 5699: CP#57 completed / Impacted TSs and TRs: 29.281
- 5700: CP#56 stopped (SA2 decided NO CT3 impact) / Impacted TSs and TRs: 29.212
- 5701: GP#55 completed. GP#51 approved WID / Impacted TSs and TRs: 48.018
- 5702: CP#57 completed. Stage 3 continuation of Rel-8 Feature SAES (3GPP System Architecture Evolution Specification - Evolved Packet System) UID_320005
- 5703: CP#57 completed / Impacted TSs and TRs: 23.122; 24.008; 24.167; 24.229; 24.301; 24.302; 24.303; 24.304; 24.305; 24.312; 29.018; 29.118
- 5704: CP#57 completed / Impacted TSs and TRs: 23.122; 24.008; 24.167; 24.229; 24.301; 24.302; 24.303; 24.304; 24.305; 24.312; 29.018; 29.118
- 5705: CP#57 completed. Stage 2/3 adding a CN internal functionality, not affecting Voice Group Call Service (VGCS)/VBS as perceived by service subscriber. Hence, no Stage 1 impact for VGCS/VBS (42.068, 42.069) / Impacted TSs and TRs: Stage 2/3
- 5706: CP#57 completed / Impacted TSs and TRs: 43.068; 43.069
- 5707: CP#56 stopped (no CT4 impact) / Impacted TSs and TRs: 29.002
- 5708: CP#57 completed. Stage 3. Support procedures and protocol extensions in RFC6140 "Registration for Multiple Phone Numbers in SIP" to IMS for complex UEs. Ensure co-existence with NGCN IP-PBX registration procedures already defined in IMS. / Impacted TSs and TRs: 24.229
- 5709: CP#57 completed. Stage 3. Stage 1 for MPS in 22.153. Details of any MGW actions for priority needs to be further studied within the scope of this WI. / Impacted TSs and TRs: Stage 3
- 5710: CP#57 completed / Impacted TSs and TRs: 23.333; 23.334; 29.232; 29.238; 29.332; 29.333; 29.334
- 5711: CP#57 completed / Impacted TSs and TRs: 29.162; 29.163; 29.292
- 5712: CP#57 completed / Impacted TSs and TRs: 29.165
- 5713: CP#59 completed. Define new AT cmd for URI addresses for IMS services (eg VoLTE). 27.007(AT cmd to control MT functions and GSM/UMTS/LTE network services from TE), 27.005(AT commands for SMS). Currently address types for AT cmd based on dialling# / Impacted TSs and TRs: 27.005; 27.007
- 5714: CP#57 completed. Stage 1 in Rel-11 SA1 TS 22.101 clause 17.7.3 (No Stage 2 needed since no architecture impact) / Impacted TSs and TRs: 23.003; 23.008; 29.002; 29.272; 29.230
- 5715: CP#57 completed / Impacted TSs and TRs: 29.364

| ID | WBS | Task | Duration | Start | Finish | Complete | Baseline start | Baseline finish | Baseline duration | Constraint | Resources | Work | Actual work | Acronym | PCG approved | WI rapporteur name | WI rapporteur e-mail | Release | TSG approved | MCC resp | Acronym_3GU_Export | PCG stopped | TSG stopped | Status Report |
| --- | --- | --- | --- | --- | --- | --- | --- | --- | --- | --- | --- | --- | --- | --- | --- | --- | --- | --- | --- | --- | --- | --- | --- | --- |
| 5716 | 1852 | **IMS Operator Determined Call Barring** | 205d? | 2012-09-07 A | 2013-06-14 A | 100% | 2012-09-07 | 2013-06-14 | 205d? |  | C1; C4 | 5411.54h | 5411.54h | IODB | 29 | Orange | Youssef.Chadli@Orange.com | Rel-11 | 57 | Frederic | IODB |  |  |  |
| 5717 | 1852.1 | CT1 part of IMS Operator Determined Call Barring | 203d? | 2012-09-10 A | 2013-06-14 A | 100% | 2012-09-10 | 2013-06-14 | 203d? | finish no earlier than 2013-06-14 | C1 | 1616h | 1616h | IODB | 29 | Orange | Youssef.Chadli@Orange.com | Rel-11 | 57 | Frederic |  |  |  |  |
| 5718 | 1852.2 | CT4 part of IMS Operator Determined Call Barring | 69d? | 2012-09-07 A | 2013-03-12 A | 100% | 2012-09-07 | 2013-03-12 | 69d? | finish no earlier than 2012-12-07 | C4 | 515.54h | 515.54h | IODB | 29 | Orange | Youssef.Chadli@Orange.com | Rel-11 | 57 | Kimmo |  |  |  |  |
| 5719 | 1853 | **Enhanced T.38 FAX support (Stage 3)** | 69d? | 2012-09-06 A | 2012-12-07 A | 100% | 2012-09-06 | 2012-12-07 | 69d? |  | C3; C1; C4 | 2728h | 2728h | MMTel_T.38_FAX | 29 | NEC | Naoaki Suzuki (n-suzuki@en.jp.nec.com) | Rel-11 | 57 | Adrian | MMTel_T.38_FAX |  |  |  |
| 5720 | 1853.1 | CT3 part of Enhanced T.38 FAX support | 68d? | 2012-09-07 A | 2012-12-07 A | 100% | 2012-09-07 | 2012-12-07 | 68d? | finish no earlier than 2012-12-07 | C3 | 528h | 528h | MMTel_T.38_FAX | 29 | NEC | Naoaki Suzuki (n-suzuki@en.jp.nec.com) | Rel-11 | 57 | Adrian |  |  |  |  |
| 5721 | 1853.2 | CT1 part of Enhanced T.38 FAX support | 67d? | 2012-09-07 A | 2012-12-07 A | 100% | 2012-09-07 | 2012-12-07 | 67d? | finish no earlier than 2012-12-07 | C1 | 528h | 528h | MMTel_T.38_FAX | 29 | NEC | Naoaki Suzuki (n-suzuki@en.jp.nec.com) | Rel-11 | 57 | Frederic |  |  |  |  |
| 5722 | 1853.3 | CT4 part of Enhanced T.38 FAX support | 2d? | 2012-09-06 A | 2012-09-07 A | 100% | 2012-09-06 | 2012-09-07 | 2d? | finish no earlier than 2012-12-07 | C4 | 16h | 16h | MMTel_T.38_FAX | 29 | NEC | Naoaki Suzuki (n-suzuki@en.jp.nec.com) | Rel-11 | 57 | Kimmo |  |  |  |  |
| 5723 | 1854 | **Deleted - Enhancement of the Protocols for SMS over SGs (Stage 3)** | 142d? | 2011-12-02 A | 2012-06-15 A | 100% | 2011-12-02 | 2012-06-15 | 142d? |  | C4; C1 | 5664h | 5664h | PROTOC_SMS_SGs | 28 | Alcatel-Lucent | jean-jacques.trottin@alcatel-lucent.com | Rel-11 | 54 | Kimmo | PROTOC_SMS_SGs | PCG-29 | CP-56 |  |
| 5724 | 1854.1 | Deleted - TR Study on enhancement of protocols for SMS service over SGs | 142d? | 2011-12-02 A | 2012-06-15 A | 100% | 2011-12-02 | 2012-06-15 | 142d? | finish no earlier than 2012-06-15 | C4 | 1128h | 1128h | PROTOC_SMS_SGs | 28 | Alcatel-Lucent | jean-jacques.trottin@alcatel-lucent.com | Rel-11 | 54 | Kimmo |  | PCG-29 | CP-56 |  |
| 5725 | 1854.2 | Deleted - CT4 part of Enhancement of the Protocols for SMS over SGs | 142d? | 2011-12-02 A | 2012-06-15 A | 100% | 2011-12-02 | 2012-06-15 | 142d? | finish no earlier than 2012-06-15 | C4 | 1128h | 1128h | PROTOC_SMS_SGs | 28 | Alcatel-Lucent | jean-jacques.trottin@alcatel-lucent.com | Rel-11 | 54 | Kimmo |  | PCG-29 | CP-56 |  |
| 5726 | 1854.3 | Deleted - CT1 part of Enhancement of the Protocols for SMS over SGs | 142d? | 2011-12-02 A | 2012-06-15 A | 100% | 2011-12-02 | 2012-06-15 | 142d? | finish no earlier than 2012-06-15 | C1 | 1136h | 1136h | PROTOC_SMS_SGs | 28 | Alcatel-Lucent | jean-jacques.trottin@alcatel-lucent.com | Rel-11 | 54 | Frederic |  | PCG-29 | CP-56 |  |
| 5727 | 1855 | **Full Support of Multi-Operator Core Network by GERAN** | 584d? | 2011-03-04 A | 2013-05-17 A | 100% | 2011-03-04 | 2013-05-17 | 584d? |  | G2; S2; C1 | 31293.3h | 31293.3h | Full_MOCN-GERAN | 26 | Alcatel-Lucent | michel.robert@alcatel-lucent.com | Rel-11 | 49 | Paolo | Full_MOCN-GERAN |  |  |  |
| 5728 | 1855.1 | GERAN part of Full Support of Multi-Operator Core Network by GERAN | 584d? | 2011-03-04 A | 2013-05-17 A | 100% | 2011-03-04 | 2013-05-17 | 584d? | finish no earlier than 2013-06-07 | G2 | 4656.4h | 4656.4h | Full_MOCN-GERAN | 26 | Alcatel-Lucent | michel.robert@alcatel-lucent.com | Rel-11 | 49 | Gert |  |  |  |  |
| 5729 | 1855.2 | Stage 2 for Full Support of Multi-Operator Core Network by GERAN | 160.8d? | 2011-06-08 A | 2012-03-07 A | 100% | 2011-06-08 | 2012-03-07 | 160.8d? | finish no earlier than 2012-03-07 | S2 | 1278.4h | 1278.4h | Full_MOCN-GERAN | 26 | Alcatel-Lucent | nicolas.drevon@alcatel-lucent.com | Rel-11 | 49 | Maurice |  |  |  |  |
| 5730 | 1855.3 | **CN Stage 3 for Full Support of Multi-Operator Core Network by GERAN** | 403d? | 2011-06-03 A | 2012-12-07 A | 100% | 2011-06-03 | 2012-12-07 | 403d? |  | C1; C4 | 9838.51h | 9838.51h | Full_MOCN-GERAN | 26 | Alcatel-Lucent | jennifer.liu@alcatel-lucent.com | Rel-11 | 49 | Frederic |  |  |  |  |
| 5731 | 1855.3.1 | CT1 part of CN Stage 3 for Full Support of Multi-Operator Core Network by GERAN | 362.8d? | 2011-06-03 A | 2012-12-07 A | 100% | 2011-06-03 | 2012-12-07 | 362.8d? | finish no earlier than 2012-12-07 | C1 | 2886.51h | 2886.51h | Full_MOCN-GERAN | 26 | Alcatel-Lucent | jennifer.liu@alcatel-lucent.com | Rel-11 | 49 | Frederic |  |  |  |  |
| 5732 | 1855.3.2 | CT4 part of CN Stage 3 for Full Support of Multi-Operator Core Network by GERAN | 64d? | 2012-06-13 A | 2012-09-07 A | 100% | 2012-06-13 | 2012-09-07 | 64d? | finish no earlier than 2012-09-07 | C4 | 504h | 504h | Full_MOCN-GERAN | 29 | Alcatel-Lucent | michel.robert@alcatel-lucent.com | Rel-11 | 54 | Kimmo |  |  |  |  |
| 5733 | 1855.4 | Stage 2 for Gateway Core Network Sharing for GERAN | 192d? | 2012-06-18 A | 2013-03-06 A | 100% | 2012-06-18 | 2013-03-06 | 192d? | finish no earlier than 2013-03-06 | S2 | 1504h | 1504h | Full_MOCN-GERAN-GWCN | 29 | Vodafone | chris.pudney@vodafone.com | Rel-11 | 56 | Maurice | Full_MOCN-GERAN-GWCN |  |  |  |
| 5734 | 1856 | **Medium range/local area requirements for multicarrier BTS** | 264d? | 2011-11-25 A | 2012-11-23 A | 100% | 2011-11-25 | 2012-11-23 | 264d? |  | G1 | 6296h | 6296h | MRLA | 28 | Ericsson | Eric Nordström | Rel-11 | 52 | Paolo | MRLA |  |  |  |
| 5735 | 1856.1 | Core part: Medium range/local area requirements for multicarrier BTS | 263d? | 2011-11-25 A | 2012-11-23 A | 100% | 2011-11-25 | 2012-11-23 | 263d? | finish no earlier than 2012-11-23 | G1 | 2096h | 2096h | MRLA-Core | 28 | Ericsson | Eric Nordström | Rel-11 | 52 | Paolo | MRLA-Core |  |  |  |
| 5736 | 1856.2 | Perf. part: Medium range/local area requirements for multicarrier BTS | 262d? | 2011-11-28 A | 2012-11-23 A | 100% | 2011-11-28 | 2012-11-23 | 262d? | finish no earlier than 2012-11-23 | G1 | 2088h | 2088h | MRLA-Perf | 28 | Ericsson | Eric Nordström | Rel-11 | 52 | Paolo | MRLA-Perf |  |  |  |
| 5737 | 1857 | Domain Specific Access Control in GERAN | 131d? | 2012-03-05 A | 2012-08-31 A | 100% | 2012-03-05 | 2012-08-31 | 131d? | finish no earlier than 2012-08-31 | G2 | 1048h | 1048h | GDSAC | 28 | Vodafone | chris.pudney@vodafone.com | Rel-11 | 53 | Gert | GDSAC |  |  |  |
| 5738 | 1858 | **Extending 850 MHz Upper Band (814 – 849 MHz)** | 589d? | 2010-12-10 A | 2013-03-01 A | 100% | 2010-12-10 | 2013-03-01 | 589d? |  | R4; R2; R3; R5 | 33352h | 33352h | e850_UB | 26 | Sprint | John.J.Humbert@Sprint.com | Rel-11 | 50 | Issam | e850_UB |  |  |  |
| 5739 | 1858.1 | Core part: Extending 850 MHz Upper Band (814 – 849 MHz) | 324d? | 2010-12-10 A | 2012-03-02 A | 100% | 2010-12-10 | 2012-03-02 | 324d? | finish no earlier than 2012-03-02 | R4; R2; R3 | 7776h | 7776h | e850_UB-Core | 26 | Sprint | John.J.Humbert@Sprint.com | Rel-11 | 50 | Issam | e850_UB-Core |  |  | RP-120075 |
| 5740 | 1858.2 | Perf. part: Extending 850 MHz Upper Band (814 – 849 MHz) | 324d? | 2010-12-10 A | 2012-03-02 A | 100% | 2010-12-10 | 2012-03-02 | 324d? | finish no earlier than 2012-03-02 | R4 | 2592h | 2592h | e850_UB-Perf | 26 | Sprint | John.J.Humbert@Sprint.com | Rel-11 | 50 | Issam | e850_UB-Perf |  |  | RP-120076 |
| 5741 | 1858.3 | Test part: Extending 850 MHz Upper Band (814 – 849 MHz) | 517d? | 2011-03-18 A | 2013-03-01 A | 100% | 2011-03-18 | 2013-03-01 | 517d? | finish no earlier than 2013-03-01 | R5 | 4136h | 4136h | e850_UB-UEConTest | 26 | Sprint | John.J.Humbert@Sprint.com | Rel-11 | 51 | Ingbert | e850_UB-UEConTest |  |  | RP-130043 |

Notes:
- 5716: LS_in C4-121615 GSMA IREG RILTE concluded that TS 22.041 clause 5.4 Stage 1 requirements are not covered by stage 3 specifications
- 5717: CP#60 completed. Handling of premium rate numbers remained OPEN in Rel-11 (shifted to Rel-12). CP-130384 LS_out sent to SA1 / GSMA informing this TSG CT decision. / Impacted TSs and TRs: New 24.315
- 5718: CP#58 completed / Impacted TSs and TRs: 23.008 ; 23.015 ; 29.328 ; 29.329 ; 29.364
- 5719: CP#58 completed. Linked to Rel-8 Feature: IMS Multimedia Telephony Service (IMS-MMTel) UID_7038. SA1 added FAX stage 1 requirement only in Rel-10 under TEI10 to TS 22.173 (CR#0064)
- 5720: CP#58 completed / Impacted TSs and TRs: 29.163
- 5721: CP#58 completed / Impacted TSs and TRs: 24.229
- 5722: CP#57 completed / Impacted TSs and TRs: 29.332
- 5723: CP#56 stopped. Reason: Protocols for SMS over SGs is replaced by the SIMTC SMS in MME solution (as solution not only for MTC user but for general subscribers) / Impacted TSs and TRs: Stage 3
- 5724: CP#56 stopped (abandonned new TR 29.818) / Impacted TSs and TRs: new 29.818
- 5725: CP#56 stopped (abandonned new TS 29.218 Diameter based protocols for SMS service over SGs) / Impacted TSs and TRs: 29.305; new 29.218
- 5726: CP#56 stopped / Impacted TSs and TRs: 23.040; 24.011; 43.068
- 5727: GP#58 completed. GP#49 approved WID. Standardization of management of MOCN supporting MSs/UES in CP-150GERAN. Continuation of Rel-10 MOCN-GERAN UID_490001 / Impacted TSs and TRs: GERAN
- 5728: GP#58 completed. GP#49 approved WID / Impacted TSs and TRs: 44.018; 44.060; 45.002; 45.008; 48.008; 48.018
- 5729: SP#55 completed / Impacted TSs and TRs: 23.251; 23.272
- 5730: CP#58 completed
- 5731: CP#58 completed / Impacted TSs and TRs: 24.008
- 5732: CP#57 completed / Impacted TSs and TRs: 23.003
- 5733: SP#59 completed. (23.251CR0062R2 as TEI11. TS 23.251 specifies both MOCN and GWCN for E-UTRAN and UTRAN, but GWCN is not yet supported on GERAN. Extend Full_MOCN-GERAN to also cover GWCN GERAN / Impacted TSs and TRs: 23.251
- 5734: GP#56 completed. GP#52 approved WID / Impacted TSs and TRs: GERAN
- 5735: Stage 3. GP#56 completed. GP#52 approved WID / Impacted TSs and TRs: 45.005
- 5736: Test spec. GP#56 completed. GP#52 approved WID / Impacted TSs and TRs: 51.021
- 5737: GP#55 completed. GP#53 approved WID. Work is dependent upon Full_MOCN-GERAN (UID_510001) / Impacted TSs and TRs: GERAN 44.018
- 5738: Stage 3. Triggered by R4 Rel-10 LTE TR 37.806 Study on Extending 850 MHz (UID_440016) / Impacted TSs and TRs: UTRA; LTE
- 5739: RP#55 completed / Impacted TSs and TRs: 25.101; 25.104; 25.113; 25.133; 25.141; 25.461; 25.466; 36.101; 36.104; 36.113; 36.124; 36.133; 36.141; 36.307; 36.331; 37.104; 37.113; 37.141
- 5740: RP#55 completed / Impacted TSs and TRs: 25.101; 25.104; 25.113; 25.133; 25.141; 25.461; 25.466; 36.101; 36.104; 36.124; 36.133; 36.141; 36.307; 36.331; 37.104; 37.113; 37.141
- 5741: RP#59 completed / Impacted TSs and TRs: 34.108; 34.121-1; 34.121-2; 34.123-1; 34.123-2; 34.123-3; 36.508; 36.521-1; 36.521-2; 36.521-3; 36.523-1; 36.523-2; 36.523-3

| ID | WBS | Task | Duration | Start | Finish | Complete | Baseline start | Baseline finish | Baseline duration | Constraint | Resources | Work | Actual work | Acronym | PCG approved | WI rapporteur name | WI rapporteur e-mail | Release | TSG approved | MCC resp | Special Focus Doc | Acronym_3GU_Export | Status Report |
| --- | --- | --- | --- | --- | --- | --- | --- | --- | --- | --- | --- | --- | --- | --- | --- | --- | --- | --- | --- | --- | --- | --- | --- |
| 5742 | 1859 | **Further Self Optimizing Networks (SON) enhancements** | 325d? | 2011-09-19 A | 2012-12-07 A | 100% | 2011-09-19 | 2012-12-07 | 325d? |  | R3; R2 | 10400h | 10400h | SONenh2_LTE_UTRA | 27 | Nokia Siemens Networks | krzysztof.kordybach@nsn.com | Rel-11 | 53 | Juha | SON | SONenh2_LTE_UTRA |  |
| 5743 | 1859.1 | Core part: Further Self Optimizing Networks (SON) enhancements | 325d? | 2011-09-19 A | 2012-12-07 A | 100% | 2011-09-19 | 2012-12-07 | 325d? | finish no earlier than 2012-12-07 | R3; R2 | 5200h | 5200h | SONenh2_LTE_UTRA-Core | 27 | Nokia Siemens Networks | krzysztof.kordybach@nsn.com | Rel-11 | 53 | Juha | SON | SONenh2_LTE_UTRA-Core | RP-121557 |
| 5744 | 1860 | **Enhancement of Minimization of Drive Tests for E-UTRAN and UTRAN** | 590d? | 2011-09-19 A | 2013-12-06 A | 100% | 2011-09-19 | 2013-12-06 | 590d? |  | R2; R1; R3; R4; R5 | 35608h | 35608h | eMDT_UMTSLTE | 27 | MediaTek | Johan Johansson | Rel-11 | 53 | Yong-Jun |  | eMDT_UMTSLTE |  |
| 5745 | 1860.1 | Core part: Enhancement of Minimization of Drive Tests for E-UTRAN and UTRAN | 325d? | 2011-09-19 A | 2012-12-07 A | 100% | 2011-09-19 | 2012-12-07 | 325d? | finish no earlier than 2012-12-07 | R2; R1; R3; R4 | 10400h | 10400h | eMDT_UMTSLTE-Core | 27 | MediaTek | Johan Johansson | Rel-11 | 53 | Yong-Jun |  | eMDT_UMTSLTE-Core | RP-121556 |
| 5746 | 1860.2 | Test part: Enhancement of Minimization of Drive Tests for E-UTRAN and UTRAN | 202d? | 2013-03-04 A | 2013-12-06 A | 100% | 2013-03-04 | 2013-12-06 | 202d? | finish no earlier than 2013-12-06 | R5 | 1608h | 1608h | eMDT_UMTSLTE-UEConTest | 30 | NTT DoCoMo | masahiro.tamaoki.eu@nttdocomo.com | Rel-11 | 59 | Ingbert |  | eMDT_UMTSLTE-UEConTest | RP-131447 |
| 5747 | 1861 | **Network Energy Saving for E-UTRAN** | 258d? | 2011-09-19 A | 2012-09-07 A | 100% | 2011-09-19 | 2012-09-07 | 258d? |  | R3; GP | 6224h | 6224h | Netw_Energy_LTE | 27 | China Mobile | yangning@chinamobile.com | Rel-11 | 53 | Juha |  | Netw_Energy_LTE |  |
| 5748 | 1861.1 | Core part: Network Energy Saving for E-UTRAN | 257d? | 2011-09-19 A | 2012-09-07 A | 100% | 2011-09-19 | 2012-09-07 | 257d? | finish no earlier than 2012-09-07 | R3 | 2056h | 2056h | Netw_Energy_LTE-Core | 27 | China Mobile | yangning@chinamobile.com | Rel-11 | 53 | Juha |  | Netw_Energy_LTE-Core | RP-121016 |
| 5749 | 1861.2 | GERAN part: Network Energy Saving for E-UTRAN | 5d? | 2012-08-27 A | 2012-08-31 A | 100% | 2012-08-27 | 2012-08-31 | 5d? | finish no earlier than 2012-08-31 | GP | 40h | 40h |  | 29 | Alcatel-Lucent | marguerite.woch@alcatel-lucent.com | Rel-11 | 55 | Paolo |  |  |  |
| 5750 | 1862 | **E-UTRA medium range and MSR medium range/local area BS class requirements** | 325d? | 2011-09-19 A | 2012-12-07 A | 100% | 2011-09-19 | 2012-12-07 | 325d? |  | R4; G1 | 12432h | 12432h | medBS_class_LTE_MSR | 27 | Ericsson | johan.skold@ericsson.com | Rel-11 | 53 | Issam |  | medBS_class_LTE_MSR |  |
| 5751 | 1862.1 | Core part: E-UTRA medium range and MSR medium range/local area BS class requirements | 323d? | 2011-09-19 A | 2012-12-07 A | 100% | 2011-09-19 | 2012-12-07 | 323d? | finish no earlier than 2012-12-07 | R4 | 2576h | 2576h | medBS_class_LTE_MSR-Core | 27 | Ericsson | johan.skold@ericsson.com | Rel-11 | 53 | Issam |  | medBS_class_LTE_MSR-Core | RP-121558 |
| 5752 | 1862.2 | Perf. part: E-UTRA medium range and MSR medium range/local area BS class requirements | 321d? | 2011-09-23 A | 2012-12-07 A | 100% | 2011-09-23 | 2012-12-07 | 321d? | finish no earlier than 2012-12-07 | R4 | 2568h | 2568h | medBS_class_LTE_MSR-Perf | 27 | Ericsson | johan.skold@ericsson.com | Rel-11 | 53 | Issam |  | medBS_class_LTE_MSR-Perf | RP-121559 |
| 5753 | 1862.3 | GERAN part: E-UTRA medium range and MSR medium range/local area BS class requirements | 261d? | 2011-11-28 A | 2012-11-23 A | 100% | 2011-11-28 | 2012-11-23 | 261d? | finish no earlier than 2012-11-23 | G1 | 2088h | 2088h | medBS_class_LTE_MSR-GERAN | 28 | Ericsson | Eric Nordström | Rel-11 | 52 | Paolo |  | medBS_class_LTE_MSR-GERAN |  |
| 5754 | 1863 | **RF Requirements for Multi-Band and Multi-Standard Radio (MB-MSR) Base Station** | 553.1d? | 2012-02-06 A | 2014-03-06 A | 100% | 2012-02-06 | 2014-03-06 | 553.1d? |  | R4; G1 | 20915.2h | 20915.2h | MB_MSR_RF | 28 | Huawei | Liu Ye (leo.liuye@huawei.com) | Rel-11 | 55 | Issam |  | MB_MSR_RF |  |
| 5755 | 1863.1 | Core part: RF Requirements for Multi-Band and Multi-Standard Radio (MB-MSR) Base Station | 223.1d? | 2012-02-06 A | 2012-12-07 A | 100% | 2012-02-06 | 2012-12-07 | 223.1d? | finish no earlier than 2012-12-07 | R4; G1 | 3569.6h | 3569.6h | MB_MSR_RF-Core | 28 | Huawei | Liu Ye (leo.liuye@huawei.com) | Rel-11 | 55 | Issam |  | MB_MSR_RF-Core | RP-121985 |
| 5756 | 1863.2 | Perf. part: RF Requirements for Multi-Band and Multi-Standard Radio (MB-MSR) Base Station | 531d? | 2012-03-08 A | 2014-03-06 A | 100% | 2012-03-08 | 2014-03-06 | 531d? | finish no earlier than 2014-03-06 | R4; G1 | 8496h | 8496h | MB_MSR_RF-Perf | 28 | Huawei | Liu Ye (leo.liuye@huawei.com) | Rel-11 | 55 | Issam |  | MB_MSR_RF-Perf | RP-140064 |
| 5757 | 1864 | **Further enhancements to H(e)NB mobility - Part 1** | 129d? | 2012-06-15 A | 2012-12-07 A | 100% | 2012-06-15 | 2012-12-07 | 129d? |  | R3; R2 | 4128h | 4128h | EHNB_enh1 | 29 | Alcatel-Lucent | Martin.Warner@alcatel-lucent.com | Rel-11 | 56 | Juha | HNB | EHNB_enh1 |  |
| 5758 | 1864.1 | Core part: Further enhancements to H(e)NB mobility - Part 1 | 129d? | 2012-06-15 A | 2012-12-07 A | 100% | 2012-06-15 | 2012-12-07 | 129d? | finish no earlier than 2012-12-07 | R3; R2 | 2064h | 2064h | EHNB_enh1-Core | 29 | Alcatel-Lucent | Martin.Warner@alcatel-lucent.com | Rel-11 | 56 | Juha | HNB | EHNB_enh1-Core | RP-121563 |
| 5759 | 1865 | **Further enhancements to H(e)NB mobility - Part 2** | 127d? | 2012-06-19 A | 2012-12-07 A | 100% | 2012-06-19 | 2012-12-07 | 127d? |  | R3; R2 | 4064h | 4064h | EHNB_enh2 | 29 | Alcatel-Lucent | Martin.Warner@alcatel-lucent.com | Rel-11 | 56 | Juha | HNB | EHNB_enh2 |  |
| 5760 | 1865.1 | Core part: Further enhancements to H(e)NB mobility - Part 2 | 127d? | 2012-06-19 A | 2012-12-07 A | 100% | 2012-06-19 | 2012-12-07 | 127d? | finish no earlier than 2012-12-07 | R3; R2 | 2032h | 2032h | EHNB_enh2-Core | 29 | Alcatel-Lucent | Martin.Warner@alcatel-lucent.com | Rel-11 | 56 | Juha | HNB | EHNB_enh2-Core | RP-121564 |
| 5761 | 1866 | **Network-Based Positioning Support for LTE** | 1391d? | 2009-03-05 A | 2014-06-13 A | 100% | 2009-03-05 | 2014-06-13 | 1391d? |  | R2; R1; R3; R4 | 91464h | 91464h | LCS_LTE-NBPS | 22 | TruePosition | terri.brooks@trueposition.com | Rel-11 | 43 | Yong-Jun |  | LCS_LTE-NBPS |  |
| 5762 | 1866.1 | Core part: Network-Based Positioning Support for LTE | 1125d? | 2009-03-05 A | 2013-06-12 A | 100% | 2009-03-05 | 2013-06-12 | 1125d? | finish no earlier than 2013-06-12 | R2; R1; R3; R4 | 36000h | 36000h | LCS_LTE-NBPS-Core | 22 | TruePosition | terri.brooks@trueposition.com | Rel-11 | 43 | Yong-Jun |  | LCS_LTE-NBPS-Core | RP-130483 |
| 5763 | 1866.2 | Perf. part: Network-Based Positioning Support for LTE | 1377d? | 2009-03-24 A | 2014-06-13 A | 100% | 2009-03-24 | 2014-06-13 | 1377d? | finish no earlier than 2014-06-13 | R4 | 11016h | 11016h | LCS_LTE-NBPS-Perf | 22 | TruePosition | terri.brooks@trueposition.com | Rel-11 | 43 | Yong-Jun |  | LCS_LTE-NBPS-Perf | RP-140626 |
| 5764 | 1867 | **Service continuity improvements for MBMS for LTE** | 993d? | 2010-06-04 A | 2014-03-06 A | 100% | 2010-06-04 | 2014-03-06 | 993d? |  | R2; R3; R5 | 35496h | 35496h | MBMS_LTE_SC | 25 | Huawei | David.Lecompte@huawei.com | Rel-11 | 48 | Yong-Jun |  | MBMS_LTE_SC |  |
| 5765 | 1867.1 | Core part: Service continuity improvements for MBMS for LTE | 596d? | 2010-06-04 A | 2012-09-07 A | 100% | 2010-06-04 | 2012-09-07 | 596d? | finish no earlier than 2012-09-07 | R2; R3 | 9536h | 9536h | MBMS_LTE_SC-Core | 25 | Huawei | David.Lecompte@huawei.com | Rel-11 | 48 | Yong-Jun |  | MBMS_LTE_SC-Core | RP-121001 |
| 5766 | 1867.2 | Test part: Service continuity improvements for MBMS for LTE | 266d? | 2013-03-04 A | 2014-03-06 A | 100% | 2013-03-04 | 2014-03-06 | 266d? | finish no earlier than 2014-03-06 | R5 | 2128h | 2128h | MBMS_LTE_SC-UEConTest | 30 | Ericsson | leif.mattisson@ericsson.com | Rel-11 | 59 | Ingbert |  | MBMS_LTE_SC-UEConTest | RP-140074 |

Notes:
- 5742: Stage 1/2/3 / Impacted TSs and TRs: UTRA; LTE
- 5743: RP#58 completed / Impacted TSs and TRs: 25.331; 25.401; 25.410; 25.413; 25.423; 25.433; 36.300; 36.331; 36.413; 36.423
- 5744: Stage 2/3 / Impacted TSs and TRs: UTRA; LTE
- 5745: RP#58 completed / Impacted TSs and TRs: 25.133; 25.123; 25.304; 25.331; 25.413; 25.423; 36.133; 36.304; 36.306; 36.331; 36.413; 36.423; 37.320; 36.300
- 5746: RP#62 completed / Impacted TSs and TRs: 34.108; 34.109; 34.123-1; 34.123-2; 34.123-3; 36.508; 36.509; 36.523-1; 36.523-2; 36.523-3
- 5747: Stage 2/3 / Impacted TSs and TRs: LTE; GERAN
- 5748: RP#57 completed. Inter-RAT aspect can affect UTRA and GERAN as well / Impacted TSs and TRs: 25.413; 36.300; 36.413; 36.423
- 5749: GP#55 approved WID and completed. Stage 3. ChangES in CP-150RIM protocol and in SON Transfer RIM application to provide support for Energy Savings Indication feature / Impacted TSs and TRs: 48.018 [Serving GPRS Support Node (SGSN); BSS GPRS protocol (BSSGP)]
- 5750: Stage 3. GERAN BS RF requirements specs need aligned with RAN4 ongoing Rel-11 Feature UID_530037 E-UTRA medium range and MSR medium range/local area BS class requirements (medBS_class_LTE_MSR) / Impacted TSs and TRs: UTRA; LTE; GERAN
- 5751: RP#58 completed. TR 37.809 v200 for Approval / Impacted TSs and TRs: 25.104; 36.104; 37.104; new 37.809
- 5752: RP#58 completed / Impacted TSs and TRs: 25.141; 36.141; 37.141
- 5753: GP#56 completed. GP#52 approved WID / Impacted TSs and TRs: 45.005; 51.021
- 5754: - / Impacted TSs and TRs: UTRA; LTE; GERAN
- 5755: RP#58 completed / Impacted TSs and TRs: 25.104; 25.105; 36.104; 37.104; new 37.812
- 5756: RP#63 completed / Impacted TSs and TRs: 25.141; 25.142; 36.141; 37.141
- 5757: Stage 2/3. Triggered by FS_EHNB_enh (UTRA, LTE TR 37.803 under AI 12.3.2). Compare also Rel-10 WI HNB_HENB_mob_enh RP-110183 / Impacted TSs and TRs: UTRA; LTE
- 5758: RP#58 completed / Impacted TSs and TRs: 25.413; 25.467; 25.469; 36.300; 36.413; 36.423
- 5759: Stage 2/3. Legacy UE Handling (X2-GW, 20% complete, moved to Rel-12 UID_580030). Triggered by FS_EHNB_enh (UTRA, LTE TR 37.803 under AI 12.3.2) / Impacted TSs and TRs: UTRA; LTE
- 5760: RP#58 completed Legacy UE Handling (X2-GW, 20% complete, moved to Rel-12 UID_580030). Updated WID RP-121147=>RP-121712 / Impacted TSs and TRs: 25.413; 25.467; 25.469; 25.471
- 5761: - / Impacted TSs and TRs: LTE
- 5762: RP#60 completed / Impacted TSs and TRs: 36.214; 36.300; 36.305; 36.401; 36.413; 36.455; new (36.111; 36.456; 36.457; 36.458; 36.459)
- 5763: RP#64 completed. TS 36.112v100 for 1-step Approval / Impacted TSs and TRs: 36.111; new 36.112
- 5764: - / Impacted TSs and TRs: LTE
- 5765: RP#57 completed / Impacted TSs and TRs: 25.446; 36.300; 36.304; 36.321; 36.322; 36.323; 36.331; 36.440; 36.441; 36.442; 36.443; 36.444; 36.445
- 5766: RP#63 completed / Impacted TSs and TRs: 36.508; 36.523-1; 36.523-2; 36.523-3

| ID | WBS | Task | Duration | Start | Finish | Complete | Baseline start | Baseline finish | Baseline duration | Constraint | Resources | Work | Actual work | Acronym | PCG approved | WI rapporteur name | WI rapporteur e-mail | Release | TSG approved | MCC resp | Acronym_3GU_Export | Status Report | Special Focus Doc |
| --- | --- | --- | --- | --- | --- | --- | --- | --- | --- | --- | --- | --- | --- | --- | --- | --- | --- | --- | --- | --- | --- | --- | --- |
| 5767 | 1868 | **Further Enhanced Non CA-based ICIC for LTE** | 991d? | 2011-03-22 A | 2014-12-15 A | 100% | 2011-03-22 | 2014-09-12 | 922d? |  | R1; R2; R3; R4; R5 | 63112h | 63112h | eICIC_enh_LTE | 26 | China Mobile | ShenXiaodong@chinamobile.com | Rel-11 | 51 | Patrick | eICIC_enh_LTE |  |  |
| 5768 | 1868.1 | Core part: Further Enhanced Non CA-based ICIC for LTE | 456d? | 2011-03-22 A | 2012-12-07 A | 100% | 2011-03-22 | 2012-12-07 | 456d? | finish no earlier than 2012-12-07 | R1; R2; R3; R4 | 14592h | 14592h | eICIC_enh_LTE-Core | 26 | China Mobile | ShenXiaodong@chinamobile.com | Rel-11 | 51 | Patrick | eICIC_enh_LTE-Core | RP-121986 |  |
| 5769 | 1868.2 | Perf. part: Further Enhanced Non CA-based ICIC for LTE | 715d? | 2011-03-23 A | 2013-12-06 A | 100% | 2011-03-23 | 2013-12-06 | 715d? | finish no earlier than 2013-12-06 | R4 | 5720h | 5720h | eICIC_enh_LTE-Perf | 26 | China Mobile | ShenXiaodong@chinamobile.com | Rel-11 | 51 | Issam | eICIC_enh_LTE-Perf | RP-131463 |  |
| 5770 | 1868.3 | Test part: Further Enhanced Non CA-based ICIC for LTE | 395d? | 2013-06-15 A | 2014-12-15 A | 100% | 2013-06-18 | 2014-09-12 | 326d? | finish no earlier than 2014-12-15 | R5 | 3160h | 3160h | eICIC_enh_LTE-UEConTest | 31 | ZTE | Carolyn Taylor (carolyn.tayl@zte.com.cn) | Rel-11 | 60 | Ingbert | eICIC_enh_LTE-UEConTest | RP-141847 |  |
| 5771 | 1869 | **New Band LTE Downlink FDD 716-728 MHz (Band 29, Carrier Aggregation of Band 2 and Band 29 and of Band 4 and Band 29)** | 456d? | 2011-03-22 A | 2012-12-07 A | 100% | 2011-03-22 | 2012-12-07 | 456d? |  | R4 | 10880h | 10880h | LTE_DL_FDD700 | 26 | AT&T | marc.grant@att.com | Rel-11 | 51 | Issam | LTE_DL_FDD700 |  | CA |
| 5772 | 1869.1 | Core part: New Band LTE Downlink FDD 716-728 MHz (Band 29), Carrier Aggregation of Band 2 and Band 29 and of Band 4 and Band 29 | 453d? | 2011-03-22 A | 2012-12-07 A | 100% | 2011-03-22 | 2012-12-07 | 453d? | finish no earlier than 2012-12-07 | R4 | 3624h | 3624h | LTE_DL_FDD700-Core | 26 | AT&T | marc.grant@att.com | Rel-11 | 51 | Issam | LTE_DL_FDD700-Core | RP-121604 |  |
| 5773 | 1869.2 | Perf. part: New Band LTE Downlink FDD 716-728 MHz (Band 29), Carrier Aggregation of Band 2 and Band 29 and of Band 4 and Band 29 | 451d? | 2011-03-29 A | 2012-12-07 A | 100% | 2011-03-29 | 2012-12-07 | 451d? | finish no earlier than 2012-12-07 | R4 | 3608h | 3608h | LTE_DL_FDD700-Perf | 26 | AT&T | marc.grant@att.com | Rel-11 | 51 | Issam | LTE_DL_FDD700-Perf | RP-121605 |  |
| 5774 | 1870 | **LTE RAN Enhancements for Diverse Data Applications** | 657d? | 2011-03-18 A | 2013-09-06 A | 100% | 2011-03-18 | 2013-09-06 | 657d? |  | R2; R5 | 15248h | 15248h | LTE_eDDA | 26 | BlackBerry | Gordon Young (gyoung@rim.com) | Rel-11 | 51 | Yong-Jun | LTE_eDDA |  |  |
| 5775 | 1870.1 | Core part: LTE RAN Enhancements for Diverse Data Applications | 456d? | 2011-03-18 A | 2012-12-07 A | 100% | 2011-03-18 | 2012-12-07 | 456d? | finish no earlier than 2012-12-07 | R2 | 3648h | 3648h | LTE_eDDA-Core | 26 | BlackBerry | Gordon Young (gyoung@rim.com) | Rel-11 | 51 | Yong-Jun | LTE_eDDA-Core | RP-121571 |  |
| 5776 | 1870.2 | Test part: LTE RAN Enhancements for Diverse Data Applications | 136d? | 2013-03-04 A | 2013-09-06 A | 100% | 2013-03-04 | 2013-09-06 | 136d? | finish no earlier than 2013-09-06 | R5 | 1088h | 1088h | LTE_eDDA-UEConTest | 30 | BlackBerry | Enikő Sokondár (esokondar@rim.com) | Rel-11 | 59 | Ingbert | LTE_eDDA-UEConTest | RP-130946 |  |
| 5777 | 1871 | **LTE E850 - Lower Band for Region 2 (non-US), Band 27** | 516d? | 2011-03-23 A | 2013-03-01 A | 100% | 2011-03-23 | 2013-03-01 | 516d? |  | R1; R2; R4; R5 | 28496h | 28496h | LTE_e850_LB | 26 | NII Holdings | bill.shvodian@nii.com | Rel-11 | 51 | Patrick | LTE_e850_LB |  |  |
| 5778 | 1871.1 | Core part: LTE E850 - Lower Band for Region 2 (non-US), Band 27 | 328d? | 2011-06-15 A | 2012-09-07 A | 100% | 2011-06-15 | 2012-09-07 | 328d? | finish no earlier than 2012-09-07 | R1; R2; R4 | 7872h | 7872h | LTE_e850_LB-Core | 26 | NII Holdings | bill.shvodian@nii.com | Rel-11 | 51 | Patrick | LTE_e850_LB-Core | RP-120570 |  |
| 5779 | 1871.2 | Perf. part: LTE E850 - Lower Band for Region 2 (non-US), Band 27 | 326d? | 2011-03-23 A | 2012-06-15 A | 100% | 2011-03-23 | 2012-06-15 | 326d? | finish no earlier than 2012-12-07 | R4 | 2608h | 2608h | LTE_e850_LB-Perf | 26 | NII Holdings | bill.shvodian@nii.com | Rel-11 | 51 | Issam | LTE_e850_LB-Perf | RP-120571 |  |
| 5780 | 1871.3 | Test part: LTE E850 - Lower Band for Region 2 (non-US), Band 27 | 189d? | 2012-06-18 A | 2013-03-01 A | 100% | 2012-06-18 | 2013-03-01 | 189d? | finish no earlier than 2013-03-01 | R5 | 1504h | 1504h | LTE_e850_LB-UEConTest | 29 | NII Holdings | bill.shvodian@nii.com | Rel-11 | 56 | Ingbert | LTE_e850_LB-UEConTest | RP-130045 |  |
| 5781 | 1872 | **LTE for 700 MHz Digital Dividend** | 538d? | 2011-06-07 A | 2013-06-14 A | 100% | 2011-06-07 | 2013-06-14 | 538d? |  | R4; R2; R3; R5 | 28032h | 28032h | LTE_APAC700 | 27 | Ericsson | olav.queseth@ericsson.com | Rel-11 | 52 | Issam | LTE_APAC700 |  |  |
| 5782 | 1872.1 | Core part: LTE for 700 MHz Digital Dividend | 273d? | 2011-06-07 A | 2012-06-15 A | 100% | 2011-06-07 | 2012-06-15 | 273d? | finish no earlier than 2012-06-15 | R4; R2; R3 | 6552h | 6552h | LTE_APAC700-Core | 27 | Ericsson | olav.queseth@ericsson.com | Rel-11 | 52 | Issam | LTE_APAC700-Core | RP-120572 |  |
| 5783 | 1872.2 | Perf. part: LTE for 700 MHz Digital Dividend | 271d? | 2011-06-09 A | 2012-06-15 A | 100% | 2011-06-09 | 2012-06-15 | 271d? | finish no earlier than 2012-06-15 | R4 | 2168h | 2168h | LTE_APAC700-Perf | 27 | Ericsson | olav.queseth@ericsson.com | Rel-11 | 52 | Issam | LTE_APAC700-Perf | RP-120573 |  |
| 5784 | 1872.3 | Test part: LTE for 700 MHz Digital Dividend | 262d? | 2012-06-18 A | 2013-06-14 A | 100% | 2012-06-18 | 2013-06-14 | 262d? | finish no earlier than 2013-06-14 | R5 | 2096h | 2096h | LTE_APAC700-UEConTest | 29 | Ericsson | fredrik.sundstrom@ericsson.com | Rel-11 | 56 | Ingbert | LTE_APAC700-UEConTest | RP-130467 |  |
| 5785 | 1873 | **Relays for LTE (part 2)** | 930d? | 2009-12-04 A | 2013-06-14 A | 100% | 2009-12-04 | 2013-06-14 | 930d? |  | R4 | 17496.4h | 17496.4h | LTE_Relay2 | 24 | Ericsson | christian.hoymann@ericsson.com | Rel-11 | 46 | Patrick | LTE_Relay2 |  |  |
| 5786 | 1873.1 | Core part: Relays for LTE (part 2) | 333d? | 2011-06-07 A | 2012-09-07 A | 100% | 2011-06-07 | 2012-09-07 | 333d? | finish no earlier than 2012-09-07 | R4 | 2656.39h | 2656.39h | LTE_Relay2-Core | 27 | Ericsson | christian.hoymann@ericsson.com | Rel-11 | 52 | Issam | LTE_Relay2-Core | RP-121008 |  |
| 5787 | 1873.2 | Perf. part: Relays for LTE (part 2) | 925d? | 2009-12-04 A | 2013-06-14 A | 100% | 2009-12-04 | 2013-06-14 | 925d? | finish no earlier than 2013-06-14 | R4 | 7400h | 7400h | LTE_Relay2-Perf | 24 | Ericsson | christian.hoymann@ericsson.com | Rel-11 | 46 | Issam | LTE_Relay2-Perf | RP-130487 |  |
| 5788 | 1874 | **Signalling and Procedure for Interference Avoidance for in-device coexistence** | 325d? | 2011-09-19 A | 2012-12-07 A | 100% | 2011-09-19 | 2012-12-07 | 325d? |  | R2; R4 | 12976h | 12976h | SPIA_IDC_LTE | 27 | China Mobile | Zhenping HU | Rel-11 | 53 | Yong-Jun | SPIA_IDC_LTE |  |  |
| 5789 | 1874.1 | Core part: Signalling and Procedure for Interference Avoidance for in-device coexistence | 325d? | 2011-09-19 A | 2012-12-07 A | 100% | 2011-09-19 | 2012-12-07 | 325d? | finish no earlier than 2012-12-07 | R2; R4 | 5200h | 5200h | SPIA_IDC_LTE-Core | 27 | China Mobile | Zhenping HU | Rel-11 | 53 | Yong-Jun | SPIA_IDC_LTE-Core | RP-121573 |  |
| 5790 | 1874.2 | Perf. part: Signalling and Procedure for Interference Avoidance for in-device coexistence | 322d? | 2011-09-20 A | 2012-12-07 A | 100% | 2011-09-20 | 2012-12-07 | 322d? | finish no earlier than 2012-12-07 | R4 | 2576h | 2576h | SPIA_IDC_LTE-Perf | 27 | China Mobile | Zhenping HU | Rel-11 | 53 | Issam | SPIA_IDC_LTE-Perf | RP-121574 |  |

Notes:
- 5767: - / Impacted TSs and TRs: LTE
- 5768: RP#58 completed / Impacted TSs and TRs: 36.101; 36.133; 36.201; 36.211; 36.212; 36.213; 36.214; 36.300; 36.304; 36.321; 36.331; 36.413; 36.423
- 5769: RP#62 completed / Impacted TSs and TRs: 36.101; 36.104; 36.133; 36.141
- 5770: ¦Stat Rep: RP-141131->RP-141847 / Impacted TSs and TRs: 36.508; 36.521-1; 36.521-2; 36.521-3; 36.523-1; 36.523-2; 36.523-3
- 5771: Stage 3 / Impacted TSs and TRs: LTE
- 5772: RP#58 completed / Impacted TSs and TRs: 36.101; 36.104; 36.141; 36.307
- 5773: RP#58 completed / Impacted TSs and TRs: 36.101; 36.104; 36.133; 36.141; 36.307
- 5774: Stage 2/3 / Impacted TSs and TRs: LTE
- 5775: RP#58 completed / Impacted TSs and TRs: 36.300; 36.321; 36.331; new 36.822
- 5776: RP#61 completed / Impacted TSs and TRs: 36.523-1; 36.523-2; 36.523-3
- 5777: Stage 3 / Impacted TSs and TRs: LTE
- 5778: RP#56 completed / Impacted TSs and TRs: 25.101; 25.104; 25.461; 25.466; 36.101; 36.104; 36.113; 36.124; 36.307; 37.104; 37.113
- 5779: RP#56 completed / Impacted TSs and TRs: 25.123; 25.133; 25.141; 36.133; 36.141; 37.141
- 5780: RP#59 completed / Impacted TSs and TRs: 36.508; 36.521-1; 36.521-2; 36.521-3; 36.523-2; 36.523-3; 37.571-1
- 5781: Stage 3. Asian Pacific American Caucus (APAC) Asia-Pacific Telecommunity (APT) Wireless Forum / Impacted TSs and TRs: LTE
- 5782: RP#56 completed. TR 36.820 v100 for Information and Approval / Impacted TSs and TRs: 25.461; 25.466; 36.101; 36.104; 36.113; 36.124; 36.133; 36.307; 37.104; 37.113; new 36.820
- 5783: RP#56 completed / Impacted TSs and TRs: 36.133; 36.141; 37.141
- 5784: RP#60 completed / Impacted TSs and TRs: 36.508; 36.521-1; 36.521-2; 36.521-3; 36.523-2; 36.523-3; 37.571-1
- 5785: Continuation of Rel-10 (open RAN4 Core & Perf parts) / Impacted TSs and TRs: LTE
- 5786: RP#57 completed. TS 36.116, TR 36.826 v100 for Information & Approval. RP#52 Core part not completed in Rel-10 / Impacted TSs and TRs: 36.133; new RAN4 (36.116; 36.826)
- 5787: RP#60 completed. New TS 36.117 v100 for 1-step Approval. RP#52 transferred completely from Rel-10 UID_460213 / Impacted TSs and TRs: 36.133; new 36.117 (E-UTRA Relay conformance testing)
- 5788: Stage 2/3 / Impacted TSs and TRs: LTE
- 5789: RP#58 completed / Impacted TSs and TRs: 36.133; 36.300; 36.306; 36.321; 36.331
- 5790: RP#58 completed / Impacted TSs and TRs: 36.133

| ID | WBS | Task | Duration | Start | Finish | Complete | Baseline start | Baseline finish | Baseline duration | Constraint | Resources | Work | Actual work | Acronym | PCG approved | WI rapporteur name | Release | TSG approved | MCC resp | Acronym_3GU_Export | Status Report | Special Focus Doc |
| --- | --- | --- | --- | --- | --- | --- | --- | --- | --- | --- | --- | --- | --- | --- | --- | --- | --- | --- | --- | --- | --- | --- |
| 5791 | 1875 | **Coordinated Multi-Point Operation for LTE** | 860d? | 2011-09-19 A | 2014-12-15 A | 100% | 2011-09-19 | 2014-09-12 | 791d? |  | R1; R2; R3; R4; R5 | 66128h | 66128h | COMP_LTE | 27 | Huawei, Samsung | Rel-11 | 53 | Patrick | COMP_LTE |  |  |
| 5792 | 1875.1 | Core part: Coordinated Multi-Point Operation for LTE – Uplink | 325d? | 2011-09-19 A | 2012-12-07 A | 100% | 2011-09-19 | 2012-12-07 | 325d? | finish no earlier than 2012-12-07 | R1; R2; R3; R4 | 10400h | 10400h | COMP_LTE_UL-Core | 27 | Huawei | Rel-11 | 53 | Patrick | COMP_LTE_UL-Core | RP-121575 |  |
| 5793 | 1875.2 | Perf. part: Coordinated Multi-Point Operation for LTE – Uplink | 321d? | 2011-09-23 A | 2012-12-07 A | 100% | 2011-09-23 | 2012-12-07 | 321d? | finish no earlier than 2012-12-07 | R4 | 2568h | 2568h | COMP_LTE_UL-Perf | 27 | Huawei | Rel-11 | 53 | Issam | COMP_LTE_UL-Perf | RP-121576 |  |
| 5794 | 1875.3 | Core part: Coordinated Multi-Point Operation for LTE – Downlink | 325d? | 2011-09-19 A | 2012-12-07 A | 100% | 2011-09-19 | 2012-12-07 | 325d? | finish no earlier than 2012-12-07 | R1; R2; R3; R4 | 10400h | 10400h | COMP_LTE_DL-Core | 27 | Samsung | Rel-11 | 53 | Patrick | COMP_LTE_DL-Core | RP-121577 |  |
| 5795 | 1875.4 | Perf. part: Coordinated Multi-Point Operation for LTE – Downlink | 582d? | 2011-09-23 A | 2013-12-06 A | 100% | 2011-09-23 | 2013-12-06 | 582d? | finish no earlier than 2013-12-06 | R4 | 4656h | 4656h | COMP_LTE_DL-Perf | 27 | Samsung | Rel-11 | 53 | Issam | COMP_LTE_DL-Perf | RP-131465 |  |
| 5796 | 1875.5 | Test part: Coordinated Multi-Point Operation for LTE | 463d? | 2013-03-15 A | 2014-12-15 A | 100% | 2013-03-04 | 2014-09-12 | 404d? | finish no earlier than 2014-12-15 | R5 | 3704h | 3704h | COMP_LTE-UEConTest | 30 | Samsung | Rel-11 | 59 | Ingbert | COMP_LTE-UEConTest | RP-141782 |  |
| 5797 | 1876 | **Enhanced downlink control channel(s) for LTE Advanced** | 732d? | 2011-12-09 A | 2014-09-12 A | 100% | 2011-12-09 | 2014-09-12 | 731d? |  | R1; R2; R4; R5 | 38272h | 38272h | LTE_enh_dl_ctrl | 28 | Alcatel-Lucent | Rel-11 | 54 | Patrick | LTE_enh_dl_ctrl |  |  |
| 5798 | 1876.1 | Core part: Enhanced downlink control channel(s) for LTE Advanced | 265d? | 2011-12-09 A | 2012-12-07 A | 100% | 2011-12-09 | 2012-12-07 | 265d? | finish no earlier than 2012-12-07 | R1; R2; R4 | 6360h | 6360h | LTE_enh_dl_ctrl-Core | 28 | Alcatel-Lucent | Rel-11 | 54 | Patrick | LTE_enh_dl_ctrl-Core | RP-121579 |  |
| 5799 | 1876.2 | Perf. part: Enhanced downlink control channel(s) for LTE Advanced | 659d? | 2011-12-16 A | 2014-06-13 A | 100% | 2011-12-16 | 2014-06-13 | 659d? | finish no earlier than 2014-06-13 | R4 | 5272h | 5272h | LTE_enh_dl_ctrl-Perf | 28 | Alcatel-Lucent | Rel-11 | 54 | Issam | LTE_enh_dl_ctrl-Perf | RP-140651 |  |
| 5800 | 1876.3 | Test part: Enhanced downlink control channel(s) for LTE Advanced | 402d? | 2013-03-04 A | 2014-09-12 A | 100% | 2013-03-04 | 2014-09-12 | 402d? | finish no earlier than 2014-09-12 | R5 | 3216h | 3216h | LTE_enh_dl_ctrl-UEConTest | 30 | Huawei | Rel-11 | 59 | Ingbert | LTE_enh_dl_ctrl-UEConTest | RP-141256 |  |
| 5801 | 1877 | **Public Safety Broadband High Power UE for Band 14 for Region 2** | 403d? | 2012-03-05 A | 2013-09-06 A | 100% | 2012-03-05 | 2013-09-06 | 403d? |  | R4; R5 | 9144h | 9144h | LTE_B14_PSBB_HPUE | 28 | Motorola Solutions | Rel-11 | 55 | Issam | LTE_B14_PSBB_HPUE |  | Public Safety (A-A) |
| 5802 | 1877.1 | Core part: Public Safety Broadband High Power UE for Band 14 for Region 2 | 201d? | 2012-03-05 A | 2012-12-07 A | 100% | 2012-03-05 | 2012-12-07 | 201d? | finish no earlier than 2012-12-07 | R4 | 1608h | 1608h | LTE_B14_PSBB_HPUE-Core | 28 | Motorola Solutions | Rel-11 | 55 | Issam | LTE_B14_PSBB_HPUE-Core | RP-121581 | Public Safety (A-A) |
| 5803 | 1877.2 | Test part: Public Safety Broadband High Power UE for Band 14 for Region 2 | 138d? | 2013-03-04 A | 2013-09-06 A | 100% | 2013-03-04 | 2013-09-06 | 138d? | finish no earlier than 2013-09-06 | R5 | 1088h | 1088h | LTE_B14_PSBB_HPUE-UEConTest | 30 | Motorola Solutions | Rel-11 | 59 | Ingbert | LTE_B14_PSBB_HPUE-UEConTest | RP-130949 | Public Safety (A-A) |
| 5804 | 1878 | **Improved Minimum Performance Requirements for E-UTRA: Interference Rejection** | 671d? | 2012-03-05 A | 2014-09-12 A | 100% | 2012-03-05 | 2014-09-12 | 670d? |  | R4; R5 | 14952h | 14952h | LTE_Interf_Rej | 28 | Renesas Mobile | Rel-11 | 55 | Issam | LTE_Interf_Rej |  |  |
| 5805 | 1878.1 | Perf. part: Improved Minimum Performance Requirements for E-UTRA: Interference Rejection | 201d? | 2012-03-05 A | 2012-12-07 A | 100% | 2012-03-05 | 2012-12-07 | 201d? | finish no earlier than 2012-12-07 | R4 | 1608h | 1608h | LTE_Interf_Rej-Perf | 28 | Renesas Mobile | Rel-11 | 55 | Issam | LTE_Interf_Rej-Perf | RP-121582 |  |
| 5806 | 1878.2 | Test part: Improved Minimum Performance Requirements for E-UTRA: Interference Rejection | 327d? | 2013-06-18 A | 2014-09-12 A | 100% | 2013-06-18 | 2014-09-12 | 327d? | finish no earlier than 2014-09-12 | R5 | 2608h | 2608h | LTE_Interf_Rej-UEConTest | 31 | Broadcom | Rel-11 | 60 | Ingbert | LTE_Interf_Rej-UEConTest | RP-141602 |  |
| 5807 | 1879 | **Additional special subframe configuration for LTE TDD** | 341d? | 2012-03-05 A | 2013-06-14 A | 100% | 2012-03-05 | 2013-06-14 | 341d? |  | R4; R2; R3; R5 | 14808h | 14808h | LTE_TDD_add_subframe | 28 | China Mobile | Rel-11 | 55 | Issam | LTE_TDD_add_subframe |  |  |
| 5808 | 1879.1 | Core part: Additional special subframe configuration for LTE TDD | 137d? | 2012-03-05 A | 2012-09-07 A | 100% | 2012-03-05 | 2012-09-07 | 137d? | finish no earlier than 2012-09-07 | R4; R2; R3 | 3288h | 3288h | LTE_TDD_add_subframe-Core | 28 | China Mobile | Rel-11 | 55 | Issam | LTE_TDD_add_subframe-Core | RP-121019 |  |
| 5809 | 1879.2 | Test part: Additional special subframe configuration for LTE TDD | 76d? | 2013-03-04 A | 2013-06-14 A | 100% | 2013-03-04 | 2013-06-14 | 76d? | finish no earlier than 2013-09-13 | R5 | 608h | 608h | LTE_TDD_add_subframe-UEConTest | 30 | Huawei | Rel-11 | 59 | Ingbert | LTE_TDD_add_subframe-UEConTest | RP-130475 |  |
| 5810 | 1880 | **Rel-11 LTE Carrier Aggregation** | 1062d? | 2010-12-10 A | 2014-12-12 A | 100% | 2010-12-10 | 2014-12-05 | 1054d? |  | R1; R2; R3; R4; R5 | 315760h | 315760h | LTE_CA_Rel-11 | 30 |  | Rel-11 | 58 | Patrick | LTE_CA_Rel-11 |  | CA |
| 5811 | 1880.1 | **LTE Carrier Aggregation Enhancements** | 995d? | 2011-03-15 A | 2014-12-12 A | 100% | 2011-03-22 | 2014-12-05 | 982d? |  | R1; R2; R3; R4; R5 | 70824h | 70824h | LTE_CA_enh | 26 | Nokia | Rel-11 | 51 | Patrick | LTE_CA_enh |  | CA |
| 5812 | 1880.1.1 | Core part: LTE Carrier Aggregation Enhancements | 646.25d? | 2011-03-22 A | 2013-08-27 A | 100% | 2011-03-22 | 2013-03-01 | 517d? | finish no earlier than 2013-03-01 | R1; R2; R4; R3 | 20680h | 20680h | LTE_CA_enh-Core | 26 | Nokia | Rel-11 | 51 | Patrick | LTE_CA_enh-Core | RP-130059 | CA |
| 5813 | 1880.1.2 | Perf. part: LTE Carrier Aggregation Enhancements | 994d? | 2011-03-15 A | 2014-12-12 A | 100% | 2011-03-29 | 2014-12-05 | 977d? | finish no earlier than 2014-12-15 | R4 | 7936h | 7936h | LTE_CA_enh-Perf | 26 | Nokia | Rel-11 | 51 | Issam | LTE_CA_enh-Perf | RP-141969 | CA |
| 5814 | 1880.1.3 | Test part: LTE Carrier Aggregation Enhancements | 326d? | 2013-06-18 A | 2014-09-12 A | 100% | 2013-06-18 | 2014-09-12 | 326d? | finish no earlier than 2014-09-12 | R5 | 2608h | 2608h | LTE_CA_enh-UEConTest | 31 | Microsoft | Rel-11 | 60 | Ingbert | LTE_CA_enh-UEConTest | RP-141443 | CA |
| 5815 | 1880.2 | UE Conformance Test Aspects – LTE Advanced Carrier Aggregation of Intra-band contiguous and Inter-band configurations | 329d? | 2012-09-11 A | 2013-12-06 A | 100% | 2012-09-11 | 2013-12-06 | 329d? | finish no earlier than 2013-12-06 | R5 | 2624h | 2624h | LTE_CA_intraC_inter_UEConTest | 29 | Nokia | Rel-11 | 57 | Ingbert | LTE_CA_intraC_inter_UEConTest | RP-131446 | CA |

Notes:
- 5791: Stage 3. Triggered by Rel-11 TR 36.819 Study on Coordinated Multi-Point Operation for LTE (FS_CoMP_LTE) / Impacted TSs and TRs: LTE / WI rapporteur e-mail: Juho Lee (juho95.lee@samsung.com), david.mazzarese@huawei.com
- 5792: RP#58 completed / Impacted TSs and TRs: 36.101; 36.104; 36.133; 36.201; 36.211; 36.212; 36.213; 36.214; 36.300; 36.306; 36.321; 36.331; 36.423 / WI rapporteur e-mail: david.mazzarese@huawei.com
- 5793: RP#58 completed / Impacted TSs and TRs: 36.101; 36.104; 36.133; 36.141 / WI rapporteur e-mail: Xinwei Zhi (zhixinwei@huawei.com)
- 5794: RP#58 completed / Impacted TSs and TRs: 36.101; 36.104; 36.133; 36.201; 36.211; 36.212; 36.213; 36.214; 36.300; 36.306; 36.321; 36.331; 36.423 / WI rapporteur e-mail: Juho Lee (juho95.lee@samsung.com)
- 5795: RP#62 completed / Impacted TSs and TRs: 36.101; 36.104; 36.133; 36.141; 36.307 / WI rapporteur e-mail: xutao.zhou@samsung.com
- 5796: Impacted TSs and TRs: 36.508; 36.521-1; 36.521-2; 36.523-1; 36.523-2; 36.523-3 / WI rapporteur e-mail: Stoyan.Baev@partner.samsung.com
- 5797: Stage 3. RP#58 Core completed. Triggered by UID_510037 Rel-11 TR 36.871 Study on further Downlink MIMO enhancements for LTE-Advanced (FS_LTE_eDL_MIMO_enh) / Impacted TSs and TRs: LTE / WI rapporteur e-mail: sigen.ye@alcatel-lucent.com
- 5798: RP#58 completed / Impacted TSs and TRs: 36.101; 36.211; 36.212; 36.213; 36.331 / WI rapporteur e-mail: sigen.ye@alcatel-lucent.com
- 5799: RP#64 completed / Impacted TSs and TRs: 36.101; 36.104; 36.133; 36.141 / WI rapporteur e-mail: teck.hu@alcatel-lucent.com
- 5800: RP#65 completed / Impacted TSs and TRs: 36.508; 36.521-1; 36.521-2; 36.523-1; 36.523-2; 36.523-3 / WI rapporteur e-mail: Xu Kai (xk.xukai@huawei.com)
- 5801: Stage 3 / Impacted TSs and TRs: LTE / WI rapporteur e-mail: xiaowei.jin@motorolasolutions.com
- 5802: RP#58 completed. TR 36.837 v100 for Information and Approval / Impacted TSs and TRs: 36.101; new 36.837 / WI rapporteur e-mail: xiaowei.jin@motorolasolutions.com
- 5803: RP#61 completed / Impacted TSs and TRs: 36.521-1; 36.521-2 / WI rapporteur e-mail: xiaowei.jin@motorolasolutions.com
- 5804: RP#58 completed. Triggered by FS_enh_perf_UE_LTE. Adds Perf. requirements for demodulation of the already specified PDSCH with the transmission modes defined in Rel-8 to Rel-10 / Impacted TSs and TRs: LTE / WI rapporteur e-mail: Timo Roman
- 5805: RP#58 completed / Impacted TSs and TRs: 36.101 / WI rapporteur e-mail: Timo Roman
- 5806: RP#65 completed. TR 36.904 for 1-step Approval. Testing for 36.101 / Impacted TSs and TRs: 36.508; 36.521-1; 36.521-2; New 36.904 / WI rapporteur e-mail: jarkko.hellsten@kolumbus.fi
- 5807: Stage 3. Exists already for 1UL a WI LTE_CA_B3_B5 / Impacted TSs and TRs: LTE / WI rapporteur e-mail: Xiaodong Shen
- 5808: RP#57 completed / Impacted TSs and TRs: 36.211; 36.213; 36.331; 36.423 / WI rapporteur e-mail: Xiaodong Shen
- 5809: RP#60 completed / Impacted TSs and TRs: 36.508; 36.523-1; 36.523-2; 36.523-3 / WI rapporteur e-mail: Li Xiang (tricia.li@huawei.com)
- 5810: LTE_CA_Rel-11 / Impacted TSs and TRs: LTE
- 5811: Stage 3 / Impacted TSs and TRs: LTE / WI rapporteur e-mail: lars.e.lindh@nokia.com
- 5812: RP#59 completed. New TR 36.823 v100 for Information and Approval / Impacted TSs and TRs: 36.101; 36.104; 36.133; 36.201; 36.211; 36.212; 36.213; 36.300; 36.302; 36.306; 36.321; 36.331; 36.413; 36.423; new 36.823 / WI rapporteur e-mail: lars.e.lindh@nokia.com
- 5813: ¦Stat Rep: RP-141377->RP-141969 / Impacted TSs and TRs: 36.101; 36.104; 36.133; 36.141 / WI rapporteur e-mail: lars.e.lindh@nokia.com
- 5814: SP#65 completed / Impacted TSs and TRs: 36.508; 36.521-1; 36.521-2; 36.521-3; 36.523-1; 36.523-2; 36.523-3 / WI rapporteur e-mail: jussi.kuusisto@microsoft.com
- 5815: RP#62 completed / Impacted TSs and TRs: 36.508; 36.521-1; 36.521-2; 36.521-3; 36.523-1; 36.523-2; 36.523-3; 37.571-1 / WI rapporteur e-mail: jussi.kuusisto@nokia.com

| ID | WBS | Task | Duration | Start | Finish | Complete | Baseline start | Baseline finish | Baseline duration | Constraint | Resources | Work | Actual work | PCG approved | Impacted TSs and TRs | Release | TSG approved | MCC resp | Special Focus Doc | Acronym | WI rapporteur name | WI rapporteur e-mail | Acronym_3GU_Export | Status Report |
| --- | --- | --- | --- | --- | --- | --- | --- | --- | --- | --- | --- | --- | --- | --- | --- | --- | --- | --- | --- | --- | --- | --- | --- | --- |
| 5816 | 1880.3 | **Rel-11 inter-band Carrier Aggregation** | 528d? | 2010-12-10 A | 2012-12-07 A | 100% | 2010-12-10 | 2012-12-07 | 528d? |  | R4 | 180968h | 180968h | 30 | LTE | Rel-11 | 58 | Issam | CA |  |  |  |  |  |
| 5817 | 1880.3.1 | **LTE Advanced Carrier Aggregation of Band 3 and Band 7** | 528d? | 2010-12-10 A | 2012-12-07 A | 100% | 2010-12-10 | 2012-12-07 | 528d? |  | R4 | 12040h | 12040h | 25 | LTE | Rel-11 | 48 | Issam | CA | LTE_CA_B3_B7 | TeliaSonera | Ralf.Schuh@TeliaSonera.com | LTE_CA_B3_B7 |  |
| 5818 | 1880.3.1.1 | Core part: LTE Advanced Carrier Aggregation of Band 3 and Band 7 | 456d? | 2010-12-10 A | 2012-09-07 A | 100% | 2010-12-10 | 2012-09-07 | 456d? | finish no earlier than 2012-09-07 | R4 | 3648h | 3648h | 25 | 36.101; 36.104; 36.307; new generic 36.850 | Rel-11 | 48 | Issam | CA | LTE_CA_B3_B7-Core | TeliaSonera | Ralf.Schuh@TeliaSonera.com | LTE_CA_B3_B7-Core | RP-121022 |
| 5819 | 1880.3.1.2 | Perf. part: LTE Advanced Carrier Aggregation of Band 3 and Band 7 | 523d? | 2010-12-17 A | 2012-12-07 A | 100% | 2010-12-17 | 2012-12-07 | 523d? | finish no earlier than 2012-12-07 | R4 | 4168h | 4168h | 25 | 36.133; 36.141 | Rel-11 | 48 | Issam | CA | LTE_CA_B3_B7-Perf | TeliaSonera | Ralf.Schuh@TeliaSonera.com | LTE_CA_B3_B7-Perf | RP-121023 |
| 5820 | 1880.3.2 | **LTE Advanced Carrier Aggregation of Band 4 and Band 17** | 528d? | 2010-12-10 A | 2012-12-07 A | 100% | 2010-12-10 | 2012-12-07 | 528d? |  | R4 | 12064h | 12064h | 26 | LTE | Rel-11 | 50 | Issam | CA | LTE_CA_B4_B17 | AT&T | marc.grant@att.com | LTE_CA_B4_B17 |  |
| 5821 | 1880.3.2.1 | Core part: LTE Advanced Carrier Aggregation of Band 4 and Band 17 | 459d? | 2010-12-10 A | 2012-09-07 A | 100% | 2010-12-10 | 2012-09-07 | 459d? | finish no earlier than 2012-09-07 | R4 | 3672h | 3672h | 26 | 36.101; 36.104; 36.133; 36.141; 36.307; new generic 36.850 | Rel-11 | 50 | Issam | CA | LTE_CA_B4_B17-Core | AT&T | marc.grant@att.com | LTE_CA_B4_B17-Core | RP-121024 |
| 5822 | 1880.3.2.2 | Perf. part: LTE Advanced Carrier Aggregation of Band 4 and Band 17 | 521d? | 2010-12-17 A | 2012-12-07 A | 100% | 2010-12-17 | 2012-12-07 | 521d? | finish no earlier than 2012-12-07 | R4 | 4168h | 4168h | 26 | 36.101; 36.104; 36.133; 36.307 | Rel-11 | 50 | Issam | CA | LTE_CA_B4_B17-Perf | AT&T | marc.grant@att.com | LTE_CA_B4_B17-Perf | RP-121595 |
| 5823 | 1880.3.3 | **LTE Advanced Carrier Aggregation of Band 4 and Band 13** | 528d? | 2010-12-10 A | 2012-12-07 A | 100% | 2010-12-10 | 2012-12-07 | 528d? |  | R4 | 12040h | 12040h | 26 | LTE | Rel-11 | 50 | Issam | CA | LTE_CA_B4_B13 | Ericsson | christian.bergljung@ericsson.com | LTE_CA_B4_B13 |  |
| 5824 | 1880.3.3.1 | Core part: LTE Advanced Carrier Aggregation of Band 4 and Band 13 | 456d? | 2010-12-10 A | 2012-09-07 A | 100% | 2010-12-10 | 2012-09-07 | 456d? | finish no earlier than 2012-09-07 | R4 | 3648h | 3648h | 26 | 36.101; 36.104; 36.133; 36.307; new generic 36.850 | Rel-11 | 50 | Issam | CA | LTE_CA_B4_B13-Core | Ericsson | christian.bergljung@ericsson.com | LTE_CA_B4_B13-Core | RP-121026 |
| 5825 | 1880.3.3.2 | Perf. part: LTE Advanced Carrier Aggregation of Band 4 and Band 13 | 521d? | 2010-12-21 A | 2012-12-07 A | 100% | 2010-12-21 | 2012-12-07 | 521d? | finish no earlier than 2012-12-07 | R4 | 4168h | 4168h | 26 | 36.101; 36.133; 36.141 | Rel-11 | 50 | Issam | CA | LTE_CA_B4_B13-Perf | Ericsson | christian.bergljung@ericsson.com | LTE_CA_B4_B13-Perf | RP-121594 |
| 5826 | 1880.3.4 | **LTE Advanced Carrier Aggregation of Band 4 and Band 12** | 456d? | 2011-03-22 A | 2012-12-07 A | 100% | 2011-03-22 | 2012-12-07 | 456d? |  | R4; R2 | 18200h | 18200h | 26 | LTE | Rel-11 | 51 | Issam | CA | LTE_CA_B4_B12 | Leap Wireless | Bill Chandler (bchandler@cricketcommunications.com) | LTE_CA_B4_B12 |  |
| 5827 | 1880.3.4.1 | Core part: LTE Advanced Carrier Aggregation of Band 4 and Band 12 | 456d? | 2011-03-22 A | 2012-12-07 A | 100% | 2011-03-22 | 2012-12-07 | 456d? | finish no earlier than 2012-12-07 | R4; R2 | 7296h | 7296h | 26 | 36.101; 36.104; 36.307; new generic 36.850 | Rel-11 | 51 | Issam | CA | LTE_CA_B4_B12-Core | Leap Wireless | Bill Chandler (bchandler@cricketcommunications.com) | LTE_CA_B4_B12-Core | RP-121592 |
| 5828 | 1880.3.4.2 | Perf. part: LTE Advanced Carrier Aggregation of Band 4 and Band 12 | 451d? | 2011-03-29 A | 2012-12-07 A | 100% | 2011-03-29 | 2012-12-07 | 451d? | finish no earlier than 2012-12-07 | R4 | 3608h | 3608h | 26 | 36.133; 36.141 | Rel-11 | 51 | Issam | CA | LTE_CA_B4_B12-Perf | Leap Wireless | Bill Chandler (bchandler@cricketcommunications.com) | LTE_CA_B4_B12-Perf | RP-121593 |
| 5829 | 1880.3.5 | **LTE Advanced Carrier Aggregation of Band 5 and Band 12** | 456d? | 2011-03-22 A | 2012-12-07 A | 100% | 2011-03-22 | 2012-12-07 | 456d? |  | R4; R2 | 18200h | 18200h | 26 | LTE | Rel-11 | 51 | Issam | CA | LTE_CA_B5_B12 | US Cellular | sebastian.thalanany@uscellular.com | LTE_CA_B5_B12 |  |
| 5830 | 1880.3.5.1 | Core part: LTE Advanced Carrier Aggregation of Band 5 and Band 12 | 456d? | 2011-03-22 A | 2012-12-07 A | 100% | 2011-03-22 | 2012-12-07 | 456d? | finish no earlier than 2012-12-07 | R4; R2 | 7296h | 7296h | 26 | 36.101; 36.104; 36.133; 36.141; 36.307; new generic 36.850 | Rel-11 | 51 | Issam | CA | LTE_CA_B5_B12-Core | US Cellular | sebastian.thalanany@uscellular.com | LTE_CA_B5_B12-Core | RP-121596 |
| 5831 | 1880.3.5.2 | Perf. part: LTE Advanced Carrier Aggregation of Band 5 and Band 12 | 451d? | 2011-03-25 A | 2012-12-07 A | 100% | 2011-03-25 | 2012-12-07 | 451d? | finish no earlier than 2012-12-07 | R4 | 3608h | 3608h | 26 | 36.101; 36.104; 36.133; 36.307 | Rel-11 | 51 | Issam | CA | LTE_CA_B5_B12-Perf | US Cellular | sebastian.thalanany@uscellular.com | LTE_CA_B5_B12-Perf | RP-121597 |
| 5832 | 1880.3.6 | **LTE Advanced Carrier Aggregation of Band 7 and Band 20** | 389d? | 2011-03-22 A | 2012-09-07 A | 100% | 2011-03-22 | 2012-09-07 | 389d? |  | R4 | 9288h | 9288h | 26 | LTE | Rel-11 | 51 | Issam | CA | LTE_CA_B7_B20 | Huawei | Steven Chen | LTE_CA_B7_B20 |  |
| 5833 | 1880.3.6.1 | Core part: LTE Advanced Carrier Aggregation of Band 7 and Band 20 | 386d? | 2011-03-22 A | 2012-09-07 A | 100% | 2011-03-22 | 2012-09-07 | 386d? | finish no earlier than 2012-09-07 | R4 | 3088h | 3088h | 26 | 36.101; 36.104; 36.307; new generic 36.850 | Rel-11 | 51 | Issam | CA | LTE_CA_B7_B20-Core | Huawei | Steven Chen | LTE_CA_B7_B20-Core | RP-121032 |
| 5834 | 1880.3.6.2 | Perf. part: LTE Advanced Carrier Aggregation of Band 7 and Band 20 | 386d? | 2011-03-25 A | 2012-09-07 A | 100% | 2011-03-25 | 2012-09-07 | 386d? | finish no earlier than 2012-09-07 | R4 | 3088h | 3088h | 26 | 36.133; 36.141 | Rel-11 | 51 | Issam | CA | LTE_CA_B7_B20-Perf | Huawei | Steven Chen | LTE_CA_B7_B20-Perf | RP-121033 |
| 5835 | 1880.3.7 | **LTE Advanced Carrier Aggregation of Band 2 and Band 17** | 455d? | 2011-03-23 A | 2012-12-07 A | 100% | 2011-03-23 | 2012-12-07 | 455d? |  | R4 | 10336h | 10336h | 26 | LTE | Rel-11 | 51 | Issam | CA | LTE_CA_B2_B17 | AT&T | marc.grant@att.com | LTE_CA_B2_B17 |  |
| 5836 | 1880.3.7.1 | Core part: LTE Advanced Carrier Aggregation of Band 2 and Band 17 | 386d? | 2011-03-23 A | 2012-09-07 A | 100% | 2011-03-23 | 2012-09-07 | 386d? | finish no earlier than 2012-09-07 | R4 | 3088h | 3088h | 26 | 36.101; 36.104; 36.133; 36.141; 36.307; new generic 36.850 | Rel-11 | 51 | Issam | CA | LTE_CA_B2_B17-Core | AT&T | marc.grant@att.com | LTE_CA_B2_B17-Core | RP-121034 |
| 5837 | 1880.3.7.2 | Perf. part: LTE Advanced Carrier Aggregation of Band 2 and Band 17 | 451d? | 2011-03-25 A | 2012-12-07 A | 100% | 2011-03-25 | 2012-12-07 | 451d? | finish no earlier than 2012-12-07 | R4 | 3608h | 3608h | 26 | 36.101; 36.104; 36.133; 36.307 | Rel-11 | 51 | Issam | CA | LTE_CA_B2_B17-Perf | AT&T | marc.grant@att.com | LTE_CA_B2_B17-Perf | RP-121585 |
| 5838 | 1880.3.8 | **LTE Advanced Carrier Aggregation of Band 4 and Band 5** | 455d? | 2011-03-23 A | 2012-12-07 A | 100% | 2011-03-23 | 2012-12-07 | 455d? |  | R4 | 10856h | 10856h | 26 | LTE | Rel-11 | 51 | Issam | CA | LTE_CA_B4_B5 | AT&T | marc.grant@att.com | LTE_CA_B4_B5 |  |
| 5839 | 1880.3.8.1 | Core part: LTE Advanced Carrier Aggregation of Band 4 and Band 5 | 451d? | 2011-03-23 A | 2012-12-07 A | 100% | 2011-03-23 | 2012-12-07 | 451d? | finish no earlier than 2012-12-07 | R4 | 3608h | 3608h | 26 | 36.101; 36.104; 36.133; 36.141; 36.307; new generic 36.850 | Rel-11 | 51 | Issam | CA | LTE_CA_B4_B5-Core | AT&T | marc.grant@att.com | LTE_CA_B4_B5-Core | RP-121757 |
| 5840 | 1880.3.8.2 | Perf. part: LTE Advanced Carrier Aggregation of Band 4 and Band 5 | 451d? | 2011-03-25 A | 2012-12-07 A | 100% | 2011-03-25 | 2012-12-07 | 451d? | finish no earlier than 2012-12-07 | R4 | 3608h | 3608h | 26 | 36.101; 36.104; 36.133; 36.307 | Rel-11 | 51 | Issam | CA | LTE_CA_B4_B5-Perf | AT&T | marc.grant@att.com | LTE_CA_B4_B5-Perf | RP-121589 |

Notes:
- 5816: LTE_CA_Rel-11
- 5817: RP#57 completed. In Europe Band 3,7,20 are interesting for LTE and LTE-Advanced deployment. Different CA combinations for these bands are of high priority for Region 1
- 5818: RP#57 completed. RP#59 new generic TR 36.850v100 for Information and Approval
- 5819: RP#57 completed
- 5820: Stage 3. RP#57 Core completed. RP#58 Perf completed
- 5821: RP#57 completed. RP#59 new generic TR 36.850v100 for Information and Approval
- 5822: RP#58 completed
- 5823: Stage 3. RP#57 Core completed. RP#58 Perf completed
- 5824: RP#57 completed
- 5825: RP#58 completed
- 5826: Stage 3. RP#58 completed
- 5827: RP#58 completed. RP#59 new generic TR 36.850v100 for Information and Approval
- 5828: RP#58 completed
- 5829: Stage 3. RP#58 completed
- 5830: RP#58 completed. RP#59 new generic TR 36.850v100 for Information and Approval
- 5831: RP#58 completed
- 5832: Stage 3. RP#57 completed
- 5833: RP#57 completed. RP#59 new generic TR 36.850v100 for Information and Approval
- 5834: RP#57 completed
- 5835: Stage 3. RP#57 Core completed. RP#58 Perf completed
- 5836: RP#57 completed. RP#59 new generic TR 36.850v100 for Information and Approval
- 5837: RP#58 completed
- 5838: Stage 3. RP#58 completed
- 5839: RP#58 completed. RP#59 new generic TR 36.850v100 for Information and Approval
- 5840: RP#58 completed

| ID | WBS | Task | Duration | Start | Finish | Complete | Baseline start | Baseline finish | Baseline duration | Constraint | Resources | Work | Actual work | Acronym | PCG approved | WI rapporteur name | WI rapporteur e-mail | Release | TSG approved | MCC resp | Special Focus Doc | Acronym_3GU_Export | Status Report |
| --- | --- | --- | --- | --- | --- | --- | --- | --- | --- | --- | --- | --- | --- | --- | --- | --- | --- | --- | --- | --- | --- | --- | --- |
| 5841 | 1880.3.9 | **LTE Advanced Carrier Aggregation of Band 5 and Band 17** | 455d? | 2011-03-23 A | 2012-12-07 A | 100% | 2011-03-23 | 2012-12-07 | 455d? |  | R4 | 10856h | 10856h | LTE_CA_B5_B17 | 26 | AT&T | marc.grant@att.com | Rel-11 | 51 | Issam | CA | LTE_CA_B5_B17 |  |
| 5842 | 1880.3.9.1 | Core part: LTE Advanced Carrier Aggregation of Band 5 and Band 17 | 451d? | 2011-03-23 A | 2012-12-07 A | 100% | 2011-03-23 | 2012-12-07 | 451d? | finish no earlier than 2012-12-07 | R4 | 3608h | 3608h | LTE_CA_B5_B17-Core | 26 | AT&T | marc.grant@att.com | Rel-11 | 51 | Issam | CA | LTE_CA_B5_B17-Core | RP-121598 |
| 5843 | 1880.3.9.2 | Perf. part: LTE Advanced Carrier Aggregation of Band 5 and Band 17 | 451d? | 2011-03-25 A | 2012-12-07 A | 100% | 2011-03-25 | 2012-12-07 | 451d? | finish no earlier than 2012-12-07 | R4 | 3608h | 3608h | LTE_CA_B5_B17-Perf | 26 | AT&T | marc.grant@att.com | Rel-11 | 51 | Issam | CA | LTE_CA_B5_B17-Perf | RP-121599 |
| 5844 | 1880.3.10 | **LTE Advanced Carrier Aggregation of Band 3 and Band 20** | 258d? | 2011-09-19 A | 2012-09-07 A | 100% | 2011-09-19 | 2012-09-07 | 258d? |  | R4 | 6168h | 6168h | LTE_CA_B3_B20 | 27 | Vodafone | tim.frost@vodafone.com | Rel-11 | 53 | Issam | CA | LTE_CA_B3_B20 |  |
| 5845 | 1880.3.10.1 | Core part: LTE Advanced Carrier Aggregation of Band 3 and Band 20 | 256d? | 2011-09-19 A | 2012-09-07 A | 100% | 2011-09-19 | 2012-09-07 | 256d? | finish no earlier than 2012-09-07 | R4 | 2048h | 2048h | LTE_CA_B3_B20-Core | 27 | Vodafone | tim.frost@vodafone.com | Rel-11 | 53 | Issam | CA | LTE_CA_B3_B20-Core | RP-121046 |
| 5846 | 1880.3.10.2 | Perf. part: LTE Advanced Carrier Aggregation of Band 3 and Band 20 | 257d? | 2011-09-20 A | 2012-09-07 A | 100% | 2011-09-20 | 2012-09-07 | 257d? | finish no earlier than 2012-09-07 | R4 | 2056h | 2056h | LTE_CA_B3_B20-Perf | 27 | Vodafone | tim.frost@vodafone.com | Rel-11 | 53 | Issam | CA | LTE_CA_B3_B20-Perf | RP-121047 |
| 5847 | 1880.3.11 | **LTE Advanced Carrier Aggregation of Band 8 and Band 20** | 325d? | 2011-09-19 A | 2012-12-07 A | 100% | 2011-09-19 | 2012-12-07 | 325d? |  | R4 | 7752h | 7752h | LTE_CA_B8_B20 | 27 | Vodafone | Luis.Anaya@vodafone.com | Rel-11 | 53 | Issam | CA | LTE_CA_B8_B20 |  |
| 5848 | 1880.3.11.1 | Core part: LTE Advanced Carrier Aggregation of Band 8 and Band 20 | 323d? | 2011-09-19 A | 2012-12-07 A | 100% | 2011-09-19 | 2012-12-07 | 323d? | finish no earlier than 2012-12-07 | R4 | 2584h | 2584h | LTE_CA_B8_B20-Core | 27 | Vodafone | Luis.Anaya@vodafone.com | Rel-11 | 53 | Issam | CA | LTE_CA_B8_B20-Core | RP-121600 |
| 5849 | 1880.3.11.2 | Perf. part: LTE Advanced Carrier Aggregation of Band 8 and Band 20 | 321d? | 2011-09-23 A | 2012-12-07 A | 100% | 2011-09-23 | 2012-12-07 | 321d? | finish no earlier than 2012-12-07 | R4 | 2568h | 2568h | LTE_CA_B8_B20-Perf | 27 | Vodafone | Luis.Anaya@vodafone.com | Rel-11 | 53 | Issam | CA | LTE_CA_B8_B20-Perf | RP-121601 |
| 5850 | 1880.3.12 | **LTE Advanced Carrier Aggregation of Band 3 and Band 5** | 258d? | 2011-09-19 A | 2012-09-07 A | 100% | 2011-09-19 | 2012-09-07 | 258d? |  | R4 | 6160h | 6160h | LTE_CA_B3_B5 | 27 | SK Telecom | Haesung Park | Rel-11 | 53 | Issam | CA | LTE_CA_B3_B5 |  |
| 5851 | 1880.3.12.1 | Core part: LTE Advanced Carrier Aggregation of Band 3 and Band 5 | 256d? | 2011-09-19 A | 2012-09-07 A | 100% | 2011-09-19 | 2012-09-07 | 256d? | finish no earlier than 2012-09-07 | R4 | 2048h | 2048h | LTE_CA_B3_B5-Core | 27 | SK Telecom | Haesung Park | Rel-11 | 53 | Issam | CA | LTE_CA_B3_B5-Core | RP-121042 |
| 5852 | 1880.3.12.2 | Perf. part: LTE Advanced Carrier Aggregation of Band 3 and Band 5 | 256d? | 2011-09-21 A | 2012-09-07 A | 100% | 2011-09-21 | 2012-09-07 | 256d? | finish no earlier than 2012-09-07 | R4 | 2048h | 2048h | LTE_CA_B3_B5-Perf | 27 | SK Telecom | Haesung Park | Rel-11 | 53 | Issam | CA | LTE_CA_B3_B5-Perf | RP-121043 |
| 5853 | 1880.3.13 | **LTE Advanced Carrier Aggregation of Band 4 and Band 7** | 325d? | 2011-09-19 A | 2012-12-07 A | 100% | 2011-09-19 | 2012-12-07 | 325d? |  | R4 | 7744h | 7744h | LTE_CA_B4_B7 | 27 | Rogers Wireless | takwing.wan@rci.rogers.com | Rel-11 | 53 | Issam | CA | LTE_CA_B4_B7 |  |
| 5854 | 1880.3.13.1 | Core part: LTE Advanced Carrier Aggregation of Band 4 and Band 7 | 322d? | 2011-09-19 A | 2012-12-07 A | 100% | 2011-09-19 | 2012-12-07 | 322d? | finish no earlier than 2012-12-07 | R4 | 2576h | 2576h | LTE_CA_B4_B7-Core | 27 | Rogers Wireless | takwing.wan@rci.rogers.com | Rel-11 | 53 | Issam | CA | LTE_CA_B4_B7-Core | RP-121590 |
| 5855 | 1880.3.13.2 | Perf. part: LTE Advanced Carrier Aggregation of Band 4 and Band 7 | 321d? | 2011-09-23 A | 2012-12-07 A | 100% | 2011-09-23 | 2012-12-07 | 321d? | finish no earlier than 2012-12-07 | R4 | 2568h | 2568h | LTE_CA_B4_B7-Perf | 27 | Rogers Wireless | takwing.wan@rci.rogers.com | Rel-11 | 53 | Issam | CA | LTE_CA_B4_B7-Perf | RP-121591 |
| 5856 | 1880.3.14 | **LTE Advanced Carrier Aggregation of Band 11 and Band 18** | 265d? | 2011-12-09 A | 2012-12-07 A | 100% | 2011-12-09 | 2012-12-07 | 265d? |  | R4; R2 | 10568h | 10568h | LTE_CA_B11_B18 | 28 | KDDI | Masaaki Obara (ms-obara@kddi.com) | Rel-11 | 54 | Issam | CA | LTE_CA_B11_B18 |  |
| 5857 | 1880.3.14.1 | Core part: LTE Advanced Carrier Aggregation of Band 11 and Band 18 | 265d? | 2011-12-09 A | 2012-12-07 A | 100% | 2011-12-09 | 2012-12-07 | 265d? | finish no earlier than 2012-12-07 | R4; R2 | 4240h | 4240h | LTE_CA_B11_B18-Core | 28 | KDDI | Masaaki Obara (ms-obara@kddi.com) | Rel-11 | 54 | Issam | CA | LTE_CA_B11_B18-Core | RP-121602 |
| 5858 | 1880.3.14.2 | Perf. part: LTE Advanced Carrier Aggregation of Band 11 and Band 18 | 261d? | 2011-12-15 A | 2012-12-07 A | 100% | 2011-12-15 | 2012-12-07 | 261d? | finish no earlier than 2012-12-07 | R4 | 2088h | 2088h | LTE_CA_B11_B18-Perf | 28 | KDDI | Masaaki Obara (ms-obara@kddi.com) | Rel-11 | 54 | Issam | CA | LTE_CA_B11_B18-Perf | RP-121603 |
| 5859 | 1880.3.15 | **LTE Advanced Carrier Aggregation of Band 1 and Band 18** | 198d? | 2011-12-09 A | 2012-09-07 A | 100% | 2011-12-09 | 2012-09-07 | 198d? |  | R4; R2 | 7904h | 7904h | LTE_CA_B1_B18 | 28 | KDDI | Masaaki Obara (ms-obara@kddi.com) | Rel-11 | 54 | Issam | CA | LTE_CA_B1_B18 |  |
| 5860 | 1880.3.15.1 | Core part: LTE Advanced Carrier Aggregation of Band 1 and Band 18 | 198d? | 2011-12-09 A | 2012-09-07 A | 100% | 2011-12-09 | 2012-09-07 | 198d? | finish no earlier than 2012-09-07 | R4; R2 | 3168h | 3168h | LTE_CA_B1_B18-Core | 28 | KDDI | Masaaki Obara (ms-obara@kddi.com) | Rel-11 | 54 | Issam | CA | LTE_CA_B1_B18-Core | RP-121052 |
| 5861 | 1880.3.15.2 | Perf. part: LTE Advanced Carrier Aggregation of Band 1 and Band 18 | 196d? | 2011-12-13 A | 2012-09-07 A | 100% | 2011-12-13 | 2012-09-07 | 196d? | finish no earlier than 2012-12-07 | R4 | 1568h | 1568h | LTE_CA_B1_B18-Perf | 28 | KDDI | Masaaki Obara (ms-obara@kddi.com) | Rel-11 | 54 | Issam | CA | LTE_CA_B1_B18-Perf | RP-121053 |
| 5862 | 1880.3.16 | **LTE Advanced Carrier Aggregation of Band 1 and Band 19** | 197d? | 2011-12-12 A | 2012-09-07 A | 100% | 2011-12-12 | 2012-09-07 | 197d? |  | R4; R2 | 6432h | 6432h | LTE_CA_B1_B19 | 28 | NTT DoCoMo | Hiromasa Umeda (umedah@nttdocomo.co.jp) | Rel-11 | 54 | Issam | CA | LTE_CA_B1_B19 |  |
| 5863 | 1880.3.16.1 | Core part: LTE Advanced Carrier Aggregation of Band 1 and Band 19 | 137d? | 2012-03-05 A | 2012-09-07 A | 100% | 2012-03-05 | 2012-09-07 | 137d? | finish no earlier than 2012-09-07 | R4; R2 | 2192h | 2192h | LTE_CA_B1_B19-Core | 28 | NTT DoCoMo | Hiromasa Umeda (umedah@nttdocomo.co.jp) | Rel-11 | 54 | Issam | CA | LTE_CA_B1_B19-Core | RP-120552 |
| 5864 | 1880.3.16.2 | Perf. part: LTE Advanced Carrier Aggregation of Band 1 and Band 19 | 136d? | 2011-12-12 A | 2012-06-15 A | 100% | 2011-12-12 | 2012-06-15 | 136d? | finish no earlier than 2012-12-07 | R4 | 1088h | 1088h | LTE_CA_B1_B19-Perf | 28 | NTT DoCoMo | Hiromasa Umeda (umedah@nttdocomo.co.jp) | Rel-11 | 54 | Issam | CA | LTE_CA_B1_B19-Perf | RP-120553 |

Notes:
- 5841: Stage 3. RP#58 completed / Impacted TSs and TRs: LTE
- 5842: RP#58 completed. RP#59 new generic TR 36.850v100 for Information and Approval / Impacted TSs and TRs: 36.101; 36.104; 36.133; 36.141; 36.307; new generic 36.850
- 5843: RP#58 completed / Impacted TSs and TRs: 36.101; 36.104; 36.133; 36.141; 36.307
- 5844: Stage 3. RP#57 completed / Impacted TSs and TRs: LTE
- 5845: RP#57 completed. RP#59 new generic TR 36.850v100 for Information and Approval / Impacted TSs and TRs: 36.101; 36.104; 36.133; 36.307; new generic 36.850
- 5846: RP#57 completed / Impacted TSs and TRs: 36.101; 36.104; 36.133; 36.141; 36.307
- 5847: Stage 3. RP#58 completed / Impacted TSs and TRs: LTE
- 5848: RP#58 completed. RP#59 new generic TR 36.850v100 for Information and Approval / Impacted TSs and TRs: 36.101; 36.104; 36.307; new generic 36.850
- 5849: RP#58 completed / Impacted TSs and TRs: 36.101; 36.104; 36.133; 36.141
- 5850: Stage 3. RP#57 completed / Impacted TSs and TRs: LTE
- 5851: RP#57 completed. RP#59 new generic TR 36.850v100 for Information and Approval / Impacted TSs and TRs: 36.101; 36.104; 36.133; 36.307; new generic 36.850
- 5852: RP#57 completed / Impacted TSs and TRs: 36.133; 36.141
- 5853: Stage 3. RP#58 completed / Impacted TSs and TRs: LTE
- 5854: RP#58 completed. RP#59 new generic TR 36.850v100 for Information and Approval / Impacted TSs and TRs: 36.101; 36.104; 36.133; 36.141; 36.307; 37.104; new generic 36.850
- 5855: RP#58 completed / Impacted TSs and TRs: 36.101; 36.104; 36.133; 36.141; 36.307
- 5856: Stage 3. RP#58 completed / Impacted TSs and TRs: LTE
- 5857: RP#58 completed. RP#59 new generic TR 36.850v100 for Information and Approval / Impacted TSs and TRs: 36.101; 36.104; 36.307; new generic 36.850
- 5858: RP#58 completed / Impacted TSs and TRs: 36.133
- 5859: Stage 3. RP#57 completed / Impacted TSs and TRs: LTE
- 5860: RP#57 completed. RP#59 new generic TR 36.850v100 for Information and Approval / Impacted TSs and TRs: 36.101; 36.104; 36.307; new generic 36.850
- 5861: RP#57 completed / Impacted TSs and TRs: 36.133; 36.141
- 5862: Stage 3. RP#56 completed. Updated WID RP-111765=>RP-120866 / Impacted TSs and TRs: LTE
- 5863: RP#56 completed. RP#59 new generic TR 36.850v100 for Information and Approval / Impacted TSs and TRs: 36.101; 36.104; 36.133; 36.307; new generic 36.850
- 5864: RP#56 completed / Impacted TSs and TRs: 36.133; 36.141

| ID | WBS | Task | Duration | Start | Finish | Complete | Baseline start | Baseline finish | Baseline duration | Constraint | Resources | Work | Actual work | Acronym | PCG approved | WI rapporteur name | Release | TSG approved | MCC resp | Special Focus Doc | Acronym_3GU_Export | Status Report |
| --- | --- | --- | --- | --- | --- | --- | --- | --- | --- | --- | --- | --- | --- | --- | --- | --- | --- | --- | --- | --- | --- | --- |
| 5865 | 1880.3.17 | **LTE Advanced Carrier Aggregation of Band 1 and Band 21** | 265d? | 2011-12-09 A | 2012-12-07 A | 100% | 2011-12-09 | 2012-12-07 | 265d? |  | R4; R2 | 9496h | 9496h | LTE_CA_B1_B21 | 28 | NTT DoCoMo | Rel-11 | 54 | Issam | CA | LTE_CA_B1_B21 |  |
| 5866 | 1880.3.17.1 | Core part: LTE Advanced Carrier Aggregation of Band 1 and Band 21 | 198d? | 2011-12-09 A | 2012-09-07 A | 100% | 2011-12-09 | 2012-09-07 | 198d? | finish no earlier than 2012-09-07 | R4; R2 | 3168h | 3168h | LTE_CA_B1_B21-Core | 28 | NTT DoCoMo | Rel-11 | 54 | Issam | CA | LTE_CA_B1_B21-Core | RP-121054 |
| 5867 | 1880.3.17.2 | Perf. part: LTE Advanced Carrier Aggregation of Band 1 and Band 21 | 263d? | 2011-12-13 A | 2012-12-07 A | 100% | 2011-12-13 | 2012-12-07 | 263d? | finish no earlier than 2012-12-07 | R4 | 2088h | 2088h | LTE_CA_B1_B21-Perf | 28 | NTT DoCoMo | Rel-11 | 54 | Issam | CA | LTE_CA_B1_B21-Perf | RP-121055 |
| 5868 | 1880.3.18 | **LTE Advanced Carrier Aggregation of Band 3 and Band 8** | 204d? | 2012-03-05 A | 2012-12-07 A | 100% | 2012-03-05 | 2012-12-07 | 204d? |  | R4 | 4864h | 4864h | LTE_CA_B3_B8 | 28 | KT | Rel-11 | 55 | Issam | CA | LTE_CA_B3_B8 |  |
| 5869 | 1880.3.18.1 | Core part: LTE Advanced Carrier Aggregation of Band 3 and Band 8 | 201d? | 2012-03-05 A | 2012-12-07 A | 100% | 2012-03-05 | 2012-12-07 | 201d? | finish no earlier than 2012-12-07 | R4 | 1608h | 1608h | LTE_CA_B3_B8-Core | 28 | KT | Rel-11 | 55 | Issam | CA | LTE_CA_B3_B8-Core | RP-121586 |
| 5870 | 1880.3.18.2 | Perf. part: LTE Advanced Carrier Aggregation of Band 3 and Band 8 | 203d? | 2012-03-06 A | 2012-12-07 A | 100% | 2012-03-06 | 2012-12-07 | 203d? | finish no earlier than 2012-12-07 | R4 | 1624h | 1624h | LTE_CA_B3_B8-Perf | 28 | KT | Rel-11 | 55 | Issam | CA | LTE_CA_B3_B8-Perf | RP-121587 |
| 5871 | 1880.4 | **Rel-11 intra-band Carrier Aggregation** | 334d? | 2011-06-07 A | 2012-09-07 A | 100% | 2011-06-07 | 2012-09-07 | 334d? |  | RP | 18864h | 18864h |  | 30 |  | Rel-11 | 58 |  | CA |  |  |
| 5872 | 1880.4.1 | **LTE Advanced Carrier Aggregation in Band 38** | 334d? | 2011-06-07 A | 2012-09-07 A | 100% | 2011-06-07 | 2012-09-07 | 334d? |  | R4 | 7976h | 7976h | LTE_CA_B38 | 27 | Huawei | Rel-11 | 52 | Issam | CA | LTE_CA_B38 |  |
| 5873 | 1880.4.1.1 | Core part: LTE Advanced Carrier Aggregation in Band 38 | 331d? | 2011-06-07 A | 2012-09-07 A | 100% | 2011-06-07 | 2012-09-07 | 331d? | finish no earlier than 2012-09-07 | R4 | 2648h | 2648h | LTE_CA_B38-Core | 27 | Huawei | Rel-11 | 52 | Issam | CA | LTE_CA_B38-Core | RP-121060 |
| 5874 | 1880.4.1.2 | Perf. part: LTE Advanced Carrier Aggregation in Band 38 | 333d? | 2011-06-08 A | 2012-09-07 A | 100% | 2011-06-08 | 2012-09-07 | 333d? | finish no earlier than 2012-09-07 | R4 | 2656h | 2656h | LTE_CA_B38-Perf | 27 | Huawei | Rel-11 | 52 | Issam | CA | LTE_CA_B38-Perf | RP-121061 |
| 5875 | 1880.4.2 | **LTE Advanced Carrier Aggregation in Band 41** | 197d? | 2011-06-07 A | 2012-03-02 A | 100% | 2011-06-07 | 2012-03-02 | 197d? |  | R4 | 4720h | 4720h | LTE_CA_B41 | 27 | Clearwire | Rel-11 | 52 | Issam | CA | LTE_CA_B41 |  |
| 5876 | 1880.4.2.1 | Core part: LTE Advanced Carrier Aggregation in Band 41 | 196d? | 2011-06-07 A | 2012-03-02 A | 100% | 2011-06-07 | 2012-03-02 | 196d? | finish no earlier than 2012-02-23 | R4 | 1568h | 1568h | LTE_CA_B41-Core | 27 | Clearwire | Rel-11 | 52 | Issam | CA | LTE_CA_B41-Core | RP-120126 |
| 5877 | 1880.4.2.2 | Perf. part: LTE Advanced Carrier Aggregation in Band 41 | 197d? | 2011-06-07 A | 2012-03-02 A | 100% | 2011-06-07 | 2012-03-02 | 197d? | finish no earlier than 2012-03-02 | R4 | 1576h | 1576h | LTE_CA_B41-Perf | 27 | Clearwire | Rel-11 | 52 | Issam | CA | LTE_CA_B41-Perf | RP-120127 |
| 5878 | 1880.4.3 | **LTE Advanced Carrier Aggregation in Band 7** | 258d? | 2011-09-19 A | 2012-09-07 A | 100% | 2011-09-19 | 2012-09-07 | 258d? |  | R4 | 6168h | 6168h | LTE_CA_B7 | 27 | China Unicom | Rel-11 | 53 | Issam | CA | LTE_CA_B7 |  |
| 5879 | 1880.4.3.1 | Core part: LTE Advanced Carrier Aggregation in Band 7 | 256d? | 2011-09-19 A | 2012-09-07 A | 100% | 2011-09-19 | 2012-09-07 | 256d? | finish no earlier than 2012-09-07 | R4 | 2048h | 2048h | LTE_CA_B7-Core | 27 | China Unicom | Rel-11 | 53 | Issam | CA | LTE_CA_B7-Core | RP-121062 |
| 5880 | 1880.4.3.2 | Perf. part: LTE Advanced Carrier Aggregation in Band 7 | 257d? | 2011-09-20 A | 2012-09-07 A | 100% | 2011-09-20 | 2012-09-07 | 257d? | finish no earlier than 2012-09-07 | R4 | 2056h | 2056h | LTE_CA_B7-Perf | 27 | China Unicom | Rel-11 | 53 | Issam | CA | LTE_CA_B7-Perf | RP-121063 |
| 5881 | 1881 | **UE Over The Air (Antenna) conformance testing methodology - Laptop mounted equipment Free Space test** | 1842d? | 2009-09-18 A | 2016-09-15 A | 100% | 2009-09-18 | 2014-12-05 | 1374d? |  | R4; R5 | 45192h | 45192h | UEAnt_FSTest | 23 | CATR | Rel-11 | 45 | Issam |  | UEAnt_FSTest |  |
| 5882 | 1881.1 | Core part: UE Over The Air (Antenna) conformance testing methodology - Laptop mounted equipment Free Space test | 583d? | 2009-09-18 A | 2011-12-09 A | 100% | 2009-09-18 | 2011-12-09 | 583d? | finish no earlier than 2011-12-09 | R4 | 4664h | 4664h | UEAnt_FSTest-Core | 23 | CATR | Rel-11 | 45 | Issam |  | UEAnt_FSTest-Core | RP-111456 |
| 5883 | 1881.2 | Test part: UE Over The Air (Antenna) conformance testing methodology - Laptop mounted equipment Free Space test | 1388d? | 2011-06-15 A | 2016-09-15 A | 100% | 2011-06-07 | 2014-12-05 | 926d? | finish no earlier than 2016-09-15 | R5 | 11056h | 11056h | UEAnt_FSTest-UEConTest | 27 | ZTE | Rel-11 | 52 | Ingbert |  | UEAnt_FSTest-UEConTest | RP-151187 |
| 5884 | 1882 | **Eight carrier HSDPA** | 589d? | 2010-09-15 A | 2012-12-07 A | 100% | 2010-09-15 | 2012-12-07 | 589d? |  | R1; R2; R3; R4 | 37768h | 37768h | 8C_HSDPA | 26 | Ericsson | Rel-11 | 50 | Patrick |  | 8C_HSDPA |  |
| 5885 | 1882.1 | Core part: Eight carrier HSDPA | 461d? | 2010-09-15 A | 2012-06-15 A | 100% | 2010-09-15 | 2012-06-15 | 461d? | finish no earlier than 2012-06-15 | R1; R2; R3; R4 | 14752h | 14752h | 8C_HSDPA-Core | 26 | Ericsson | Rel-11 | 50 | Patrick |  | 8C_HSDPA-Core | RP-120971 |
| 5886 | 1882.2 | Perf. part: Eight carrier HSDPA | 523d? | 2010-12-15 A | 2012-12-07 A | 100% | 2010-12-15 | 2012-12-07 | 523d? | finish no earlier than 2012-12-07 | R4 | 4168h | 4168h | 8C_HSDPA-Perf | 26 | Ericsson | Rel-11 | 50 | Issam |  | 8C_HSDPA-Perf | RP-120972 |
| 5887 | 1883 | **UE demodulation performance requirements under multiple-cell scenario for 1.28Mcps TDD** | 324d? | 2010-12-10 A | 2012-03-02 A | 100% | 2010-12-10 | 2012-03-02 | 324d? |  | R4; R5 | 7760h | 7760h | LCR_TDD_UE_demod_mc | 26 | China Mobile | Rel-11 | 50 | Issam |  | LCR_TDD_UE_demod_mc |  |
| 5888 | 1883.1 | Perf. part: UE demodulation performance requirements under multiple-cell scenario for 1.28Mcps TDD | 201d? | 2010-12-10 A | 2011-09-16 A | 100% | 2010-12-10 | 2011-09-16 | 201d? | finish no earlier than 2011-09-16 | R4 | 1608h | 1608h | LCR_TDD_UE_demod_mc-Perf | 26 | China Mobile | Rel-11 | 50 | Issam |  | LCR_TDD_UE_demod_mc-Perf | RP-110996 |
| 5889 | 1883.2 | Test part: UE demodulation performance requirements under multiple-cell scenario for 1.28Mcps TDD | 121d? | 2011-09-19 A | 2012-03-02 A | 100% | 2011-09-19 | 2012-03-02 | 121d? | finish no earlier than 2012-02-23 | R5 | 968h | 968h | LCR_TDD_UE_demod_mc-UEConTest | 27 | China Mobile | Rel-11 | 53 | Ingbert |  | LCR_TDD_UE_demod_mc-UEConTest | RP-120052 |

Notes:
- 5865: Stage 3. RP#57 completed. Updated WID RP-111764=>RP-121173 / Impacted TSs and TRs: LTE / WI rapporteur e-mail: Hiromasa Umeda (umedah@nttdocomo.co.jp)
- 5866: RP#57 completed. RP#59 new generic TR 36.850v100 for Information and Approval / Impacted TSs and TRs: 36.101; 36.104; 36.133; 36.307; new generic 36.850 / WI rapporteur e-mail: Hiromasa Umeda (umedah@nttdocomo.co.jp)
- 5867: RP#57 completed / Impacted TSs and TRs: 36.133; 36.141 / WI rapporteur e-mail: Hiromasa Umeda (umedah@nttdocomo.co.jp)
- 5868: Stage 3. RP#58 completed / Impacted TSs and TRs: LTE / WI rapporteur e-mail: Chungwoo HWANG (cwhwang@kt.com)
- 5869: RP#58 completed. RP#59 new generic TR 36.850v100 for Information and Approval / Impacted TSs and TRs: 36.101; 36.104; 36.133; 36.307; new generic 36.850 / WI rapporteur e-mail: Chungwoo HWANG (cwhwang@kt.com)
- 5870: RP#58 completed / Impacted TSs and TRs: 36.133; 36.141 / WI rapporteur e-mail: Chungwoo HWANG (cwhwang@kt.com)
- 5871: LTE_CA_Rel-11 / Impacted TSs and TRs: LTE
- 5872: Stage 3. RP#57 completed. WI only covers intra-band contiguous and not non-contiguous aspects / Impacted TSs and TRs: LTE / WI rapporteur e-mail: ronnie.zhang@huawei.com
- 5873: RP#57 completed. TR 36.830 v100 for Information & Approval / Impacted TSs and TRs: 36.101; 36.104; 36.133; 36.141; 36.307; 37.104; 37.141; new 36.833-1-38 [instead of 36.830] / WI rapporteur e-mail: ronnie.zhang@huawei.com
- 5874: RP#57 completed / Impacted TSs and TRs: 36.101; 36.104; 36.133; 36.141; 36.307; 37.104; 37.141 / WI rapporteur e-mail: ronnie.zhang@huawei.com
- 5875: RP#55 completed. WI only covers intra-band contiguous and not non-contiguous aspects. / Impacted TSs and TRs: LTE / WI rapporteur e-mail: michael.hart@clearwire.com
- 5876: RP#55 completed. Updated WID RP-110673=>RP-120249. TR 36.827 v100 for Information + Approval / Impacted TSs and TRs: 36.101; 36.104; 36.133; 36.141; 36.307; 37.104; new 36.833-1-41 [instead of 36.827] / WI rapporteur e-mail: michael.hart@clearwire.com
- 5877: RP#55 completed / Impacted TSs and TRs: 36.101; 36.104; 36.133; 36.141; 36.307 / WI rapporteur e-mail: michael.hart@clearwire.com
- 5878: Stage 3. RP#57 completed. Updated WID RP-111356=>RP-121193. WI only covers intra-band contiguous and not non-contiguous aspects / Impacted TSs and TRs: LTE / WI rapporteur e-mail: Zhangchao Ma (mazc@chinaunicom.cn), Zhonghao Zhang (zhangzh306@chinaunicom.cn)
- 5879: RP#57 completed. TR 36.831 v100 for Information & Approval / Impacted TSs and TRs: 36.101; 36.104; 36.133; 36.141; 36.307; 37.104; 37.141; new 36.833-1-07 [instead of 36.831] / WI rapporteur e-mail: Zhangchao Ma (mazc@chinaunicom.cn), Zhonghao Zhang (zhangzh306@chinaunicom.cn)
- 5880: RP#57 completed / Impacted TSs and TRs: 36.101; 36.104; 36.133; 36.141; 36.307; 37.104; 37.141 / WI rapporteur e-mail: Zhangchao Ma (mazc@chinaunicom.cn), Zhonghao Zhang (zhangzh306@chinaunicom.cn)
- 5881: - / Impacted TSs and TRs: UTRA / WI rapporteur e-mail: Guo Lin (guolin@emcite.com)
- 5882: RP#54 completed / Impacted TSs and TRs: 25.144; 25.914; 34.114 / WI rapporteur e-mail: Guo Lin (guolin@emcite.com)
- 5883: 1st Apr 15: CD:Mon 15/06/15->Wed 15/06/16 1st Apr 15: Stat Rep: RP-141846->RP-150068 03/07/15: Stat Rep: RP-150068->RP-150603 29/09/15: Stat Rep: RP-150603->RP-151187 / Impacted TSs and TRs: 34.114 / WI rapporteur e-mail: carolyn.tayl@zte.com.cn
- 5884: Stage 3 / Impacted TSs and TRs: UTRA / WI rapporteur e-mail: johan.hultell@ericsson.com
- 5885: RP#57 completed / Impacted TSs and TRs: 25.101; 25.104; 25.133; 25.211; 25.212; 25.213; 25.214; 25.215; 25.308; 25.331; 25.423; 25.433; 26.306 / WI rapporteur e-mail: johan.hultell@ericsson.com
- 5886: RP#57 completed / Impacted TSs and TRs: 25.101; 25.104; 25.133; 25.141 / WI rapporteur e-mail: johan.hultell@ericsson.com
- 5887: Stage 3 / Impacted TSs and TRs: UTRA / WI rapporteur e-mail: Li Nan (linan@chinamobile.com)
- 5888: RP#53 completed. TR 25.873v100 for Approval / Impacted TSs and TRs: 25.102; new 25.873 / WI rapporteur e-mail: Li Nan (linan@chinamobile.com)
- 5889: RP#55 completed / Impacted TSs and TRs: 34.108; 34.122 / WI rapporteur e-mail: Ma Shuai (mashuai@chinamobile.com)

| ID | WBS | Task | Duration | Start | Finish | Complete | Baseline start | Baseline finish | Baseline duration | Constraint | Resources | Work | Actual work | Acronym | PCG approved | WI rapporteur name | WI rapporteur e-mail | Release | TSG approved | MCC resp | Acronym_3GU_Export | Status Report |
| --- | --- | --- | --- | --- | --- | --- | --- | --- | --- | --- | --- | --- | --- | --- | --- | --- | --- | --- | --- | --- | --- | --- |
| 5890 | 1884 | **Uplink Transmit Diversity for HSPA** | 929d? | 2010-12-10 A | 2014-06-13 A | 100% | 2010-12-10 | 2014-06-13 | 929d? |  | R1; R4; R2; R3; R5 | 83568.3h | 83568.3h | HSPA_UL_TxDiv | 26 | Huawei | zongjie.wang@huawei.com | Rel-11 | 50 | Patrick | HSPA_UL_TxDiv |  |
| 5891 | 1884.1 | Core part: Uplink Transmit Diversity for HSPA - Closed Loop | 528d? | 2010-12-10 A | 2012-12-07 A | 100% | 2010-12-10 | 2012-12-07 | 528d? | finish no earlier than 2012-12-07 | R1; R4; R2; R3 | 16896h | 16896h | HSPA_UL_TxDiv-CL-Core | 26 | Huawei | zongjie.wang@huawei.com | Rel-11 | 50 | Patrick | HSPA_UL_TxDiv-CL-Core | RP-121542 |
| 5892 | 1884.2 | Perf. part: Uplink Transmit Diversity for HSPA - Closed Loop | 721d? | 2010-12-14 A | 2013-09-06 A | 100% | 2010-12-14 | 2013-09-06 | 721d? | finish no earlier than 2013-09-06 | R4 | 5760.31h | 5760.31h | HSPA_UL_TxDiv-CL-Perf | 26 | Huawei | zongjie.wang@huawei.com | Rel-11 | 50 | Issam | HSPA_UL_TxDiv-CL-Perf | RP-130477 |
| 5893 | 1884.3 | Core part: Uplink Transmit Diversity for HSPA - Open Loop | 528d? | 2010-12-10 A | 2012-12-07 A | 100% | 2010-12-10 | 2012-12-07 | 528d? | finish no earlier than 2012-12-07 | R4; R1; R2; R3 | 16896h | 16896h | HSPA_UL_TxDiv-OL-Core | 26 | Huawei | zongjie.wang@huawei.com | Rel-11 | 50 | Patrick | HSPA_UL_TxDiv-OL-Core | RP-121544 |
| 5894 | 1884.4 | Perf. part: Uplink Transmit Diversity for HSPA - Open Loop | 521d? | 2010-12-14 A | 2012-12-07 A | 100% | 2010-12-14 | 2012-12-07 | 521d? | finish no earlier than 2012-12-07 | R4 | 4168h | 4168h | HSPA_UL_TxDiv-OL-Perf | 26 | Huawei | zongjie.wang@huawei.com | Rel-11 | 50 | Issam | HSPA_UL_TxDiv-OL-Perf | RP-121545 |
| 5895 | 1884.5 | Test part: Uplink Transmit Diversity for HSPA | 336d? | 2013-03-04 A | 2014-06-13 A | 100% | 2013-03-04 | 2014-06-13 | 336d? | finish no earlier than 2014-06-13 | R5 | 2688h | 2688h | HSPA_UL_TxDiv-UEConTest | 30 | Qualcomm | Shubhang Vora (svora@qti.qualcomm.com) | Rel-11 | 59 | Ingbert | HSPA_UL_TxDiv-UEConTest | RP-140767 |
| 5896 | 1885 | **Introduction of New Configuration for 4C-HSDPA** | 328d? | 2011-03-22 A | 2012-06-15 A | 100% | 2011-03-22 | 2012-06-15 | 328d? |  | R4; R2 | 10928h | 10928h | 4C_HSDPA_Config | 26 | Telus Communications | jorge.delrio@telus.com | Rel-11 | 51 | Issam | 4C_HSDPA_Config |  |
| 5897 | 1885.1 | Core part: Introduction of New Configuration for 4C-HSDPA | 192d? | 2011-03-22 A | 2011-12-09 A | 100% | 2011-03-22 | 2011-12-09 | 192d? | finish no earlier than 2011-12-09 | R4; R2 | 3072h | 3072h | 4C_HSDPA_Config-Core | 26 | Telus Communications | jorge.delrio@telus.com | Rel-11 | 51 | Issam | 4C_HSDPA_Config-Core | RP-111463 |
| 5898 | 1885.2 | Perf. part: Introduction of New Configuration for 4C-HSDPA | 326d? | 2011-03-24 A | 2012-06-15 A | 100% | 2011-03-24 | 2012-06-15 | 326d? | finish no earlier than 2012-06-15 | R4 | 2608h | 2608h | 4C_HSDPA_Config-Perf | 26 | Telus Communications | jorge.delrio@telus.com | Rel-11 | 51 | Issam | 4C_HSDPA_Config-Perf | RP-120475 |
| 5899 | 1886 | **Non-contiguous 4C-HSDPA operation** | 516d? | 2011-03-23 A | 2013-03-01 A | 100% | 2011-03-23 | 2013-03-01 | 516d? |  | R4; R2; R3 | 24360h | 24360h | NC_4C_HSDPA | 26 | Ericsson | muhammad.kazmi@ericsson.com | Rel-11 | 51 | Issam | NC_4C_HSDPA |  |
| 5900 | 1886.1 | Core part: Non-contiguous 4C-HSDPA operation | 328d? | 2011-06-15 A | 2012-09-07 A | 100% | 2011-06-15 | 2012-09-07 | 328d? | finish no earlier than 2012-09-07 | R4; R2; R3 | 7872h | 7872h | NC_4C_HSDPA-Core | 26 | Ericsson | muhammad.kazmi@ericsson.com | Rel-11 | 51 | Issam | NC_4C_HSDPA-Core | RP-120842 |
| 5901 | 1886.2 | Perf. part: Non-contiguous 4C-HSDPA operation | 513d? | 2011-03-23 A | 2013-03-01 A | 100% | 2011-03-23 | 2013-03-01 | 513d? | finish no earlier than 2013-03-01 | R4 | 4104h | 4104h | NC_4C_HSDPA-Perf | 26 | Ericsson | muhammad.kazmi@ericsson.com | Rel-11 | 51 | Issam | NC_4C_HSDPA-Perf | RP-130049 |
| 5902 | 1887 | **Further Enhancements to CELL_FACH** | 1057d? | 2011-03-18 A | 2015-03-13 A | 100% | 2011-03-18 | 2014-09-12 | 924d? |  | R1; R2; R3; R4; R5 | 66320h | 66320h | Cell_FACH_enh | 26 | Qualcomm | Ravi Agarwal | Rel-11 | 51 | Patrick | Cell_FACH_enh |  |
| 5903 | 1887.1 | Core part: Further Enhancements to CELL_FACH | 458d? | 2011-03-18 A | 2012-12-07 A | 100% | 2011-03-18 | 2012-12-07 | 458d? | finish no earlier than 2012-12-07 | R2; R1; R3; R4 | 14656h | 14656h | Cell_FACH_enh-Core | 26 | Qualcomm | Ravi Agarwal | Rel-11 | 51 | Yong-Jun | Cell_FACH_enh-Core | RP-121547 |
| 5904 | 1887.2 | Perf. part: Further Enhancements to CELL_FACH | 717d? | 2011-03-24 A | 2013-12-06 A | 100% | 2011-03-24 | 2013-12-06 | 717d? | finish no earlier than 2013-12-06 | R4 | 5728h | 5728h | Cell_FACH_enh-Perf | 26 | Qualcomm | Heechoon Lee (heechoon@qti.qualcomm.com) | Rel-11 | 51 | Issam | Cell_FACH_enh-Perf | RP-131459 |
| 5905 | 1887.3 | Test part: Further Enhancements to CELL_FACH | 457d? | 2013-06-15 A | 2015-03-13 A | 100% | 2013-06-18 | 2014-09-12 | 327d? | finish no earlier than 2015-03-15 | R5 | 3656h | 3656h | Cell_FACH_enh-UEConTest | 31 | Ericsson | leif.mattisson@ericsson.com | Rel-11 | 60 | Ingbert | Cell_FACH_enh-UEConTest | RP-150132 |
| 5906 | 1888 | **HSDPA Multiflow Data Transmission** | 924d? | 2011-09-19 A | 2015-03-13 A | 100% | 2011-09-19 | 2014-12-05 | 851d? |  | R2; R1; R3; R4; R5 | 54136h | 54136h | HSDPA_MFTX | 27 | Nokia Siemens Networks | Alexander Sayenko | Rel-11 | 53 | Yong-Jun | HSDPA_MFTX |  |
| 5907 | 1888.1 | Core part: HSDPA Multiflow Data Transmission | 325d? | 2011-09-19 A | 2012-12-07 A | 100% | 2011-09-19 | 2012-12-07 | 325d? | finish no earlier than 2012-12-07 | R2; R1; R3; R4 | 10400h | 10400h | HSDPA_MFTX-Core | 27 | Nokia Siemens Networks | Alexander Sayenko | Rel-11 | 53 | Yong-Jun | HSDPA_MFTX-Core | RP-121551 |
| 5908 | 1888.2 | Perf. part: HSDPA Multiflow Data Transmission | 519d? | 2011-09-20 A | 2013-09-06 A | 100% | 2011-09-20 | 2013-09-06 | 519d? | finish no earlier than 2013-09-06 | R4 | 4152h | 4152h | HSDPA_MFTX-Perf | 27 | Nokia Siemens Networks | kamil.bechta@nsn.com | Rel-11 | 53 | Issam | HSDPA_MFTX-Perf | RP-130959 |
| 5909 | 1888.3 | Test part: HSDPA Multiflow Data Transmission | 328d? | 2013-12-15 A | 2015-03-13 A | 100% | 2013-12-06 | 2014-12-05 | 262d? | finish no earlier than 2015-03-15 | R5 | 2624h | 2624h | HSDPA_MFTX-UEConTest | 32 | Qualcomm | Shubhang Vora (svora@qti.qualcomm.com) | Rel-11 | 62 | Ingbert | HSDPA_MFTX-UEConTest | RP-150126 |
| 5910 | 1889 | **Four Branch MIMO transmission for HSDPA** | 590d? | 2011-09-19 A | 2013-12-06 A | 100% | 2011-09-19 | 2013-12-06 | 590d? |  | R1; R2; R3; R4 | 33968h | 33968h | 4Tx_HSDPA | 27 | Ericsson | johan.hultell@ericsson.com | Rel-11 | 53 | Patrick | 4Tx_HSDPA |  |
| 5911 | 1889.1 | Core part: Four Branch MIMO transmission for HSDPA | 325d? | 2011-09-19 A | 2012-12-07 A | 100% | 2011-09-19 | 2012-12-07 | 325d? | finish no earlier than 2012-12-07 | R1; R2; R3; R4 | 10400h | 10400h | 4Tx_HSDPA-Core | 27 | Ericsson | johan.hultell@ericsson.com | Rel-11 | 53 | Patrick | 4Tx_HSDPA-Core | RP-121549 |
| 5912 | 1889.2 | Perf. part: Four Branch MIMO transmission for HSDPA | 586d? | 2011-09-21 A | 2013-12-06 A | 100% | 2011-09-21 | 2013-12-06 | 586d? | finish no earlier than 2013-12-06 | R4 | 4688h | 4688h | 4Tx_HSDPA-Perf | 27 | Ericsson | johan.hultell@ericsson.com | Rel-11 | 53 | Issam | 4Tx_HSDPA-Perf | RP-131460 |
| 5913 | 1890 | **MIMO with 64QAM for HSUPA** | 464d? | 2011-12-09 A | 2013-09-06 A | 100% | 2011-12-09 | 2013-09-06 | 464d? |  | R1; R2; R3; R4 | 26984h | 26984h | MIMO_64QAM_HSUPA | 28 | Nokia Siemens Networks | Karri Ranta-aho | Rel-11 | 54 | Patrick | MIMO_64QAM_HSUPA |  |
| 5914 | 1890.1 | Core part: MIMO with 64QAM for HSUPA | 265d? | 2011-12-09 A | 2012-12-07 A | 100% | 2011-12-09 | 2012-12-07 | 265d? | finish no earlier than 2012-12-07 | R1; R2; R3; R4 | 8480h | 8480h | MIMO_64QAM_HSUPA-Core | 28 | Nokia Siemens Networks | Karri Ranta-aho | Rel-11 | 54 | Patrick | MIMO_64QAM_HSUPA-Core | RP-121554 |
| 5915 | 1890.2 | Perf. part: MIMO with 64QAM for HSUPA | 457d? | 2011-12-13 A | 2013-09-06 A | 100% | 2011-12-13 | 2013-09-06 | 457d? | finish no earlier than 2013-09-06 | R4 | 3656h | 3656h | MIMO_64QAM_HSUPA-Perf | 28 | Nokia Siemens Networks | kamil.bechta@nsn.com | Rel-11 | 54 | Issam | MIMO_64QAM_HSUPA-Perf | RP-130960 |

Notes:
- 5890: Stage 2/3 / Impacted TSs and TRs: UTRA
- 5891: RP#58 completed / Impacted TSs and TRs: 25.101; 25.104; 25.133; 25.211; 25.212; 25.213; 25.214; 25.215; 25.306; 25.319; 25.321; 25.331; 25.423; 25.433
- 5892: RP#61 completed / Impacted TSs and TRs: 25.101; 25.104; 25.133; 25.141
- 5893: RP#58 completed / Impacted TSs and TRs: 25.101; 25.133; 25.306; 25.319; 25.321; 25.331; 25.423; 25.433
- 5894: RP#58 completed / Impacted TSs and TRs: 25.101; 25.133
- 5895: RP#64 completed / Impacted TSs and TRs: 34.121-1; 34.121-2; 34.123-1; 34.123-2; 34.123-3
- 5896: - / Impacted TSs and TRs: UTRA
- 5897: RP#54 completed. RP#62 existing TS 25.317 replaced by new TS 25.327 / Impacted TSs and TRs: 25.101; 25.104; 25.141; 25.317 replaced by new 25.327
- 5898: RP#56 completed. RP#62 existing TS 25.317 replaced by new TS 25.327 / Impacted TSs and TRs: 25.101; 25.104; 25.141; 25.317 replaced by new 25.327
- 5899: - / Impacted TSs and TRs: UTRA
- 5900: RP#56 completed / Impacted TSs and TRs: 25.101; 25.104; 25.133; 25.331; 25.423; 25.433
- 5901: RP#59 completed / Impacted TSs and TRs: 25.101; 25.104; 25.133; 25.141
- 5902: - / Impacted TSs and TRs: UTRA
- 5903: RP#58 completed / Impacted TSs and TRs: 25.101; 25.104; 25.133; 25.211; 25.212; 25.213; 25.214; 25.306; 25.308; 25.319; 25.321; 25.331; 25.423; 25.433
- 5904: RP#62 completed / Impacted TSs and TRs: 25.101; 25.104; 25.133; 25.141
- 5905: ¦Stat Rep: RP-141164->RP-141770 1st Apr 15: Compl:92%->100% 1st Apr 15: Stat Rep: RP-141770->RP-150132 / Impacted TSs and TRs: 34.108; 34.121-1; 34.121-2; 34.123-1; 34.123-2; 34.123-3; 36.508; 36.523-1; 36.523-2; 36.523-3
- 5906: Stage 2,3 / Impacted TSs and TRs: UTRA
- 5907: RP#58 completed / Impacted TSs and TRs: 25.101; 25.104; 25.133; 25.211; 25.212; 25.214; 25.306; 25.308; 25.321; 25.331; 25.423; 25.433
- 5908: RP#61 completed / Impacted TSs and TRs: 25.101; 25.104; 25.133; 25.141
- 5909: ¦Stat Rep: RP-141136->RP-141961 1st Apr 15: Compl:90%->100% 1st Apr 15: Stat Rep: RP-141961->RP-150126 / Impacted TSs and TRs: 34.108; 34.121-1; 34.121-2; 34.123-1; 34.123-2; 34.123-3
- 5910: Stage 3 / Impacted TSs and TRs: UTRA
- 5911: RP#58 completed / Impacted TSs and TRs: 25.101; 25.104; 25.133; 25.211; 25.212; 25.213; 25.214; 25.215; 25.308; 25.331; 25.423; 25.433; 26.306
- 5912: RP#62 completed / Impacted TSs and TRs: 25.101; 25.104; 25.133; 25.141
- 5913: Specified UE and BS performance requirements for uplink MIMO together with QPSK and 16QAM modulations for E-DCH/HSUPA. 64QAM is for future releases / Impacted TSs and TRs: UTRA
- 5914: RP#58 completed / Impacted TSs and TRs: 25.101; 25.104; 25.133; 25.211; 25.212; 25.213; 25.214; 25.215; 25.308; 25.321; 25.331; 25.423; 25.433; 26.306
- 5915: RP#61 completed / Impacted TSs and TRs: 25.101; 25.104; 25.133; 25.141

| ID | WBS | Task | Type | Duration | Start | Finish | Complete | Baseline start | Baseline finish | Baseline duration | Constraint | Resources | Work | Actual work | Acronym | PCG approved | Impacted TSs and TRs | WI rapporteur name | Release | TSG approved | MCC resp | Acronym_3GU_Export | Status Report | Special Focus Doc | PCG stopped | TSG stopped |
| --- | --- | --- | --- | --- | --- | --- | --- | --- | --- | --- | --- | --- | --- | --- | --- | --- | --- | --- | --- | --- | --- | --- | --- | --- | --- | --- |
| 5916 | 1891 | **HSDPA Dual-Band Multi-Carrier combinations** |  | 198d? | 2011-12-09 A | 2012-09-07 A | 100% | 2011-12-09 | 2012-09-07 | 198d? |  | R4; R2 | 7920h | 7920h | HSDPA_DB_MC | 28 | UTRA | Ericsson | Rel-11 | 54 | Issam | HSDPA_DB_MC |  |  |  |  |
| 5917 | 1891.1 | Core part: HSDPA Dual-Band Multi-Carrier combinations |  | 198d? | 2011-12-09 A | 2012-09-07 A | 100% | 2011-12-09 | 2012-09-07 | 198d? | finish no earlier than 2012-09-07 | R4; R2 | 3168h | 3168h | HSDPA_DB_MC-Core | 28 | 25.101; 25.104; 25.141; 25.317 replaced by new 25.327 | Ericsson | Rel-11 | 54 | Issam | HSDPA_DB_MC-Core | RP-120987 |  |  |  |
| 5918 | 1891.2 | Perf. part: HSDPA Dual-Band Multi-Carrier combinations |  | 198d? | 2011-12-09 A | 2012-09-07 A | 100% | 2011-12-09 | 2012-09-07 | 198d? | finish no earlier than 2012-09-07 | R4 | 1584h | 1584h | HSDPA_DB_MC-Perf | 28 | 25.101; 25.104; 25.141 | Ericsson | Rel-11 | 54 | Issam | HSDPA_DB_MC-Perf | RP-120988 |  |  |  |
| 5919 | 1892 | Split TTCN Test Models for IMS testing in TS 34.229-3 |  | 201d? | 2013-12-09 A | 2014-09-12 A | 100% | 2013-12-09 | 2014-09-12 | 201d? | finish no earlier than 2014-09-12 | R5 | 1608h | 1608h | IMS-CCR_Test2 | 32 | 34.229-3; New 34.229-4 | Spirent | Rel-11 | 62 | Ingbert | IMS-CCR_Test2 | RP-141155 |  |  |  |
| 5920 | 1893 | (Small) Technical Enhancements and Improvements for Rel-11 |  | 595d? | 2010-06-18 A | 2012-09-20 A | 100% | 2010-06-18 | 2012-09-20 | 595d? | finish no earlier than 2012-09-20 | SP; CP; RP; GP | 19040h | 19040h | TEI11 | 25 |  |  | Rel-11 | 48 | All | TEI11 |  |  |  |  |
| 5921 | 1894 | Test - (Small) Technical Enhancements and Improvements for Rel-11 |  | 397d? | 2012-06-15 A | 2013-12-11 A | 100% | 2012-06-15 | 2013-12-11 | 397d? | finish no earlier than 2013-12-11 | R5; G3new | 6352h | 6352h | TEI11_Test | 29 |  |  | Rel-11 | 56 | Ingbert | TEI11_Test |  |  |  |  |
| 5922 | 1895 | (IETF) (Small) Technical Enhancements and Improvements for Rel-11 (RFC 7077) |  | 333d? | 2012-09-07 A | 2013-12-06 A | 100% | 2012-09-07 | 2013-12-06 | 333d? | finish no earlier than 2013-11-28 | C4-IETF | 2632.95h | 2632.95h | TEI11_IETF | 29 | RFC 7077 (was draft-ietf-netext-update-notifications) | Lionel Morand | Rel-11 | 57 | Kimmo | TEI11_IETF |  |  |  |  |
| 5923 | 1896 | Release 11 Studies | milestone | 0d? | 2009-12-10 A | 2009-12-10 A | 100% | 2009-12-10 | 2012-09-14 | 727d? | finish no earlier than 2012-12-07 | SP; CP; GP; RP |  |  |  |  |  |  | Rel-11 |  | All |  |  |  |  |  |
| 5924 | 1897 | Study on IMS based Peer-to-Peer Content Distribution Services |  | 195d? | 2009-09-11 A | 2010-06-10 A | 100% | 2009-05-12 | 2010-06-10 | 284d? | finish no earlier than 2010-06-10 | S1; S2 | 3120h | 3120h | FS_IMS_P2P | 23 | 22.906 | China Mobile | Rel-11 | 45 | Alain | FS_IMS_P2P |  |  |  |  |
| 5925 | 1898 | Study on Non Voice Emergency Services |  | 467d? | 2009-12-10 A | 2011-09-21 A | 100% | 2009-12-10 | 2011-09-21 | 467d? | finish no earlier than 2011-09-21 | S1 | 3720h | 3720h | FS_NOVES | 24 | 22.871 | Qualcomm | Rel-11 | 46 | Alain | FS_NOVES |  |  |  |  |
| 5926 | 1899 | Study on Support for 3GPP Voice Interworking with Enterprise IP-PBX |  | 130d? | 2010-09-23 A | 2011-03-23 A | 100% | 2010-09-23 | 2011-03-23 | 130d? | finish no earlier than 2011-02-21 | S1; S2 | 2080h | 2080h | FS_VINE | 25 | 22.809 | Tatara Systems | Rel-11 | 48 | Alain | FS_VINE |  |  |  |  |
| 5927 | 1900 | Study on IMS Network-Independent Public User Identities |  | 185d? | 2010-09-23 A | 2011-06-08 A | 100% | 2010-09-23 | 2011-06-08 | 185d? | finish no earlier than 2011-06-08 | S1 | 1480h | 1480h | FS_INIPUI | 25 | 22.894 | Vodafone | Rel-11 | 49 | Alain | FS_INIPUI |  |  |  |  |
| 5928 | 1901 | Study on IMS Evolution |  | 849d? | 2008-09-18 A | 2011-12-14 A | 100% | 2008-09-18 | 2011-12-14 | 849d? | finish no earlier than 2011-12-07 | S2 | 6784h | 6784h | FS_eIMS | 21 | 23.812 | China Mobile | Rel-11 | 41 | Maurice | FS_eIMS |  |  |  |  |
| 5929 | 1902 | Study on Policy solutions and enhancements |  | 521d? | 2009-06-12 A | 2011-06-10 A | 100% | 2000-01-03 | 2002-01-03 | 525d? | finish no earlier than 2011-06-10 | S2; S1 | 8336h | 8336h | FS_PP | 23 | 23.813 | AT&T | Rel-11 | 44 | Maurice | FS_PP |  |  |  |  |
| 5930 | 1903 | Study on IPv6 Migration |  | 525d? | 2009-06-04 A | 2011-06-08 A | 100% | 2009-06-04 | 2011-06-08 | 525d? | finish no earlier than 2011-06-08 | S2 | 4200h | 4200h | FS_IP6M | 23 | 23.975 | China Mobile | Rel-11 | 44 | Maurice | FS_IP6M |  |  |  |  |
| 5931 | 1904 | Study on Single Radio Voice Call Continuity from UTRAN/GERAN to E-UTRAN/HSPA |  | 528d? | 2009-12-10 A | 2011-12-14 A | 100% | 2009-12-10 | 2011-12-14 | 528d? | finish no earlier than 2011-09-21 | S2 | 4208h | 4208h | FS_rSRVCC | 24 | 23.885 | Orange | Rel-11 | 46 | Maurice | FS_rSRVCC |  |  |  |  |
| 5932 | 1905 | Study on Roaming Architecture for Voice over IMS with Local Breakout |  | 194d? | 2011-03-23 A | 2011-12-14 A | 100% | 2011-03-23 | 2011-12-14 | 194d? | finish no earlier than 2011-12-07 | S2 | 1535.79h | 1535.79h | FS_RAVEL | 26 | 23.850 | Deutsche Telekom | Rel-11 | 51 | Maurice | FS_RAVEL |  |  |  |  |
| 5933 | 1906 | Study on UTRAN key management enhancements |  | 1102d? | 2007-12-20 A | 2012-03-07 A | 100% | 2007-12-20 | 2012-03-07 | 1102d? | finish no earlier than 2012-02-20 | S3 | 8808.12h | 8808.12h | FS_UKM | 21 | 33.859 | Ericsson | Rel-11 | 38 | Mirko | FS_UKM |  |  |  |  |
| 5934 | 1907 | Study on Single Sign On (SSO) Application Security for IMS - based on SIP Digest |  | 532d? | 2010-06-10 A | 2012-06-20 A | 100% | 2010-06-10 | 2012-06-20 | 532d? | finish no earlier than 2012-06-20 | S3 | 4247.09h | 4247.09h | FS_SSO_APS | 25 | 33.914 converted to 33.804 | Nokia | Rel-11 | 48 | Mirko | FS_SSO_APS |  |  |  |  |
| 5935 | 1908 | Study on Mobile 3D Video Coding |  | 273d? | 2011-06-08 A | 2012-06-20 A | 100% | 2011-06-08 | 2012-06-20 | 273d? | finish no earlier than 2012-06-20 | S4 | 2168h | 2168h | FS_M3DVC | 27 | 26.905 | Orange | Rel-11 | 52 | Paolo | FS_M3DVC |  |  |  |  |
| 5936 | 1909 | Study on Management of Converged Networks |  | 591d? | 2010-06-10 A | 2012-09-12 A | 100% | 2010-06-10 | 2012-09-12 | 591d? | finish no earlier than 2012-09-12 | S5 | 4720h | 4720h | FS_ManCon | 25 | 32.833 | Nokia Siemens Networks | Rel-11 | 48 | Mirko | FS_ManCon |  |  |  |  |
| 5937 | 1910 | Study on User Data Convergence (UDC) information model handling and provisioning: Example Use Cases |  | 321d? | 2010-09-23 A | 2011-12-14 A | 100% | 2010-09-23 | 2011-12-14 | 321d? | finish no earlier than 2011-12-14 | S5 | 2560h | 2560h | FS_UDC_AppUseCase | 25 | 32.901 | Alcatel-Lucent | Rel-11 | 49 | Mirko | FS_UDC_AppUseCase |  |  |  |  |
| 5938 | 1911 | Study on OAM aspects of inter-RAT Energy Saving |  | 194d? | 2011-03-23 A | 2011-12-14 A | 100% | 2011-03-23 | 2011-12-14 | 194d? | start no earlier than 2011-03-23 | S5 | 1528h | 1528h | FS_OAM_ES_iRAT | 26 | 32.834 | Nokia Siemens Networks | Rel-11 | 51 | Mirko | FS_OAM_ES_iRAT |  | SON |  |  |
| 5939 | 1912 | Study on impacts on UE-Core Network signalling from Energy Saving |  | 261d? | 2010-06-04 A | 2011-06-03 A | 100% | 2010-06-04 | 2011-06-03 | 261d? | finish no earlier than 2011-06-03 | C1 | 2088h | 2088h | FS_UE-CN_ES | 25 | 24.826 | NEC | Rel-11 | 48 | Frederic | FS_UE-CN_ES |  |  |  |  |
| 5940 | 1913 | Study on EPC Nodes Restoration |  | 588d? | 2010-09-17 A | 2012-12-07 A | 100% | 2010-09-17 | 2012-12-07 | 588d? | finish no earlier than 2012-12-07 | C4 | 4664h | 4664h | FS_EPC_NR | 25 | 23.857 | ZTE | Rel-11 | 49 | Kimmo | FS_EPC_NR |  |  |  |  |
| 5941 | 1914 | Study on Signal Precoding enhancements for EGPRS2 DL |  | 394d? | 2010-09-03 A | 2012-03-02 A | 100% | 2010-09-03 | 2012-03-02 | 394d? | finish no earlier than 2012-03-02 | G1; G2 | 6304h | 6304h | FS_SPEED | 25 | GERAN 45.860 | Ericsson | Rel-11 | 46 | Paolo | FS_SPEED |  |  |  |  |
| 5942 | 1915 | Study on Coordinated Multi-Point operation for LTE |  | 203d? | 2010-12-10 A | 2011-09-16 A | 100% | 2010-12-10 | 2011-09-16 | 203d? | finish no earlier than 2011-09-16 | R1; R2; R3 | 4872h | 4872h | FS_CoMP_LTE | 24 | LTE 36.819 | Samsung | Rel-11 | 47 | Patrick | FS_CoMP_LTE | RP-111343 |  |  |  |
| 5943 | 1916 | Study on Signalling and procedure for interference avoidance for in-device coexistence |  | 338d? | 2010-06-04 A | 2011-09-16 A | 100% | 2010-06-04 | 2011-09-16 | 338d? | finish no earlier than 2011-09-16 | R2; R4 | 5408h | 5408h | FS_SPIA_IDC | 25 | LTE 36.816 | China Mobile | Rel-11 | 48 | Yong-Jun | FS_SPIA_IDC | RP-111057 |  |  |  |
| 5944 | 1917 | Study on HetNet mobility enhancements for LTE |  | 391d? | 2011-03-18 A | 2012-09-07 A | 100% | 2011-03-18 | 2012-09-07 | 391d? | finish no earlier than 2012-09-07 | R2; R1; R3; R4 | 12512h | 12512h | FS_HetNet_eMOB_LTE | 26 | LTE 36.839 | Alcatel-Lucent | Rel-11 | 51 | Yong-Jun | FS_HetNet_eMOB_LTE | RP-121085 |  |  |  |
| 5945 | 1918 | Study on further Downlink MIMO enhancements for LTE-Advanced |  | 193d? | 2011-03-18 A | 2011-12-09 A | 100% | 2011-03-18 | 2011-12-09 | 193d? | finish no earlier than 2011-12-09 | R1 | 1544h | 1544h | FS_LTE_eDL_MIMO_enh | 26 | LTE 36.871 | Alcatel-Lucent | Rel-11 | 51 | Patrick | FS_LTE_eDL_MIMO_enh | RP-111550 |  |  |  |
| 5946 | 1919 | Study on Further Enhancements to LTE TDD for DL-UL Interference Management and Traffic Adaptation |  | 328d? | 2011-03-22 A | 2012-06-15 A | 100% | 2011-03-22 | 2012-06-15 | 328d? | finish no earlier than 2012-06-15 | R1; R4 | 5248h | 5248h | FS_LTE_TDD_eIMTA | 26 | LTE 36.828 | CATT | Rel-11 | 51 | Patrick | FS_LTE_TDD_eIMTA | RP-120587 | Small cell |  |  |
| 5947 | 1920 | Study on LTE Coverage Enhancements |  | 197d? | 2011-09-19 A | 2012-06-15 A | 100% | 2011-09-19 | 2012-06-15 | 197d? | finish no earlier than 2012-06-15 | R1; R2 | 3152h | 3152h | FS_Cov_Enh_LTE | 27 | LTE 36.824 | China Telecom | Rel-11 | 53 | Patrick | FS_Cov_Enh_LTE | RP-120589 |  |  |  |
| 5948 | 1921 | Study on Enhanced performance requirement for LTE UE |  | 121d? | 2011-09-19 A | 2012-03-02 A | 100% | 2011-09-19 | 2012-03-02 | 121d? | finish no earlier than 2012-03-02 | R4; R1 | 1936h | 1936h | FS_enh_perf_UE_LTE | 27 | LTE 36.829 | NTT DoCoMo | Rel-11 | 53 | Issam | FS_enh_perf_UE_LTE | RP-120167 |  |  |  |
| 5949 | 1922 | Study on Measurements of radio performances for LTE terminals - Total Radiated Power (TRP) and Total Radiated Sensitivity (TRS) test methodology |  | 136d? | 2012-03-05 A | 2012-09-07 A | 100% | 2012-03-05 | 2012-09-07 | 136d? | finish no earlier than 2012-09-07 | R4 | 1088h | 1088h | FS_LTE_OTA | 28 | LTE 25.914; New 37.902 | CATR | Rel-11 | 55 | Issam | FS_LTE_OTA | RP-121083 |  |  |  |
| 5950 | 1923 | Study on Measurement of Radiated Performance for MIMO and multi-antenna reception for HSPA and LTE terminals |  | 712.8d? | 2009-03-06 A | 2012-03-02 A | 100% | 2009-03-06 | 2012-03-02 | 712.8d? | finish no earlier than 2012-03-02 | R4 | 5702.4h | 5702.4h | FS_HSPA_LTE_measRP_MIMO_multi-antenna | 22 | UTRA; LTE 37.976 | Vodafone | Rel-11 | 43 | Issam | FS_HSPA_LTE_measRP_MIMO_multi-antenna | RP-120154 |  |  |  |
| 5951 | 1924 | Study on Extending 850 MHz |  | 860d? | 2009-05-30 A | 2012-09-07 A | 100% | 2009-05-30 | 2012-09-07 | 860d? | finish no earlier than 2012-09-07 | R4 | 6880h | 6880h | FS_e850 | 23 | UTRA; LTE 37.806 | Ericsson | Rel-11 | 44 | Issam | FS_e850 | RP-121080 |  |  |  |
| 5952 | 1925 | Study on RAN improvements for Machine-Type Communications |  | 523d? | 2009-09-18 A | 2011-09-16 A | 100% | 2009-09-18 | 2011-09-16 | 523d? | finish no earlier than 2011-09-16 | R2; R1; R3; R4 | 16736h | 16736h | FS_NIMTC_RAN | 23 | UTRA; LTE 37.868 | Huawei | Rel-11 | 45 | Yong-Jun | FS_NIMTC_RAN | RP-111052 | MTC, M2M |  |  |
| 5953 | 1926 | Study on UE Application Layer Data Throughput Performance |  | 264d? | 2010-09-16 A | 2011-09-16 A | 100% | 2010-09-16 | 2011-09-16 | 264d? | finish no earlier than 2011-09-16 | R5; R4 | 4224h | 4224h | FS_UE_App_Data_Perf | 26 | UTRA; LTE 37.901 | Spirent | Rel-11 | 50 | Ingbert | FS_UE_App_Data_Perf | RP-111543 |  |  |  |
| 5954 | 1927 | Study on further enhancements for HNB and HeNB |  | 330d? | 2011-03-18 A | 2012-06-15 A | 100% | 2011-03-18 | 2012-06-15 | 330d? | finish no earlier than 2012-06-15 | R3; R2 | 5280h | 5280h | FS_EHNB_enh | 26 | UTRA; LTE 37.803 | Alcatel-Lucent | Rel-11 | 51 | Juha | FS_EHNB_enh | RP-120579 | HNB |  |  |
| 5955 | 1928 | Study on Interference analysis between 800~900 MHz bands |  | 326d? | 2011-03-23 A | 2012-06-15 A | 100% | 2011-03-23 | 2012-06-15 | 326d? | finish no earlier than 2012-06-15 | R4 | 2608h | 2608h | FS_B800_B900_Interf_LTE | 26 | UTRA; LTE impac37.804 | LG Uplus | Rel-11 | 51 | Issam | FS_B800_B900_Interf_LTE | RP-120586 |  |  |  |
| 5956 | 1929 | Study on UMTS/LTE in 900 MHz band (Japan, Korea) |  | 272d? | 2011-06-07 A | 2012-06-15 A | 100% | 2011-06-07 | 2012-06-15 | 272d? | finish no earlier than 2012-06-15 | R4 | 2176h | 2176h | FS_UTRA_LTE_900MHz | 27 | UTRA; LTE 37.804 | NTT DoCoMo | Rel-11 | 52 | Issam | FS_UTRA_LTE_900MHz | RP-120580 |  |  |  |
| 5957 | 1930 | Study on Uplink MIMO |  | 203d? | 2010-12-10 A | 2011-09-16 A | 100% | 2010-12-10 | 2011-09-16 | 203d? | finish no earlier than 2011-09-16 | R1 | 1624h | 1624h | FS_UTRA_UL_MIMO | 26 | UTRA 25.871 | Qualcomm | Rel-11 | 50 | Patrick | FS_UTRA_UL_MIMO | RP-111048 |  |  |  |
| 5958 | 1931 | Study on HSDPA Multipoint Transmission |  | 203d? | 2010-12-10 A | 2011-09-16 A | 100% | 2010-12-10 | 2011-09-16 | 203d? | finish no earlier than 2011-09-16 | R1; R2; R3 | 4872h | 4872h | FS_HSDPA_MP_TX | 26 | UTRA 25.872 | Nokia Siemens Networks | Rel-11 | 50 | Patrick | FS_HSDPA_MP_TX | RP-111049 |  |  |  |
| 5959 | 1932 | Study on UE Over The Air (OTA) test method with Head and Hand Phantoms |  | 258d? | 2011-09-19 A | 2012-09-07 A | 100% | 2011-09-19 | 2012-09-07 | 258d? | finish no earlier than 2012-09-07 | R4; R5 | 4128h | 4128h | FS_OTA_phantoms_UTRA | 27 | UTRA 25.914 | Nokia | Rel-11 | 53 | Issam | FS_OTA_phantoms_UTRA | RP-121078 |  |  |  |
| 5960 | 1933 | Study on HSPA feedback and signalling efficiency enhancements for LCR TDD |  | 199d? | 2011-12-07 A | 2012-09-07 A | 100% | 2011-12-07 | 2012-09-07 | 199d? | finish no earlier than 2012-09-07 | R1 | 1584h | 1584h | FS_LCRTDD_HSPAenh | 28 | UTRA 25.874 | TD Tech | Rel-11 | 54 | Patrick | FS_LCRTDD_HSPAenh | RP-121079 |  |  |  |
| 5961 | 1934 | Deleted - Study on Enhanced Uplink Transmission for LTE |  | 328d? | 2011-03-22 A | 2012-06-15 A | 100% | 2011-03-22 | 2012-06-15 | 328d? | finish no earlier than 2012-06-15 | R1 | 2624h | 2624h | FS_eUL_TX_LTE | 26 | LTE 36.8xy | Huawei | Rel-11 | 51 | Patrick | FS_eUL_TX_LTE | RP-120585 |  | PCG-29 | RP-56 |
| 5962 | 1935 | --- RELEASE 10 --- |  | 728d? | 2008-12-11 A | 2011-09-21 A | 100% | 2008-12-11 | 2011-09-21 | 728d? | finish no earlier than 2011-09-21 | CP; GP; RP; SP | 23296h | 23296h |  |  |  |  | Rel-10 |  |  |  |  |  |  |  |

Notes:
- 5916: Stage 3 / WI rapporteur e-mail: muhammad.kazmi@ericsson.com
- 5917: RP#57 completed. RP#62 existing TS 25.317 replaced by new TS 25.327 / WI rapporteur e-mail: muhammad.kazmi@ericsson.com
- 5918: RP#57 completed / WI rapporteur e-mail: muhammad.kazmi@ericsson.com
- 5919: SP#65 completed. TS 34.229-4 for Approval. Split out of old TS 34.229-3 a new TS 34.229-4 / WI rapporteur e-mail: richard.catmur@spirent.com
- 5920: SP#50 EU-Alert is introduced under Public Warning System in parallel with the already existing ETWS and CMAS. SA1 22.268 CR#9r1 adds EU-ALERT specific requirements & CT1 23.041 CRs#
- 5921: -
- 5922: CP#62 completed / WI rapporteur e-mail: Lionel Morand
- 5923: -
- 5924: SP#48 completed. 3/3/15: start date corrected (was 05/09) / WI rapporteur e-mail: Li Gang (ligangyf@chinamobile.com)
- 5925: SP#53 completed. Spin-off Feature UID_500030 Non Voice Emergency Services (NOVES) / WI rapporteur e-mail: dwilliams@qualcomm.com
- 5926: SP#51 completed. Support Interworking between 3GPP networks and Enterprise environments to provide enterprise voice services via 3GPP mobile devices / WI rapporteur e-mail: Phillip Brown (pbrown@tatarasystems.com)
- 5927: SP#52 completed / WI rapporteur e-mail: mona.mustapha@vodafone.com
- 5928: SP#54 completed / WI rapporteur e-mail: Li Gang (ligangyf@chinamobile.com), Yu Qing (yuqing@chinamobile.com)
- 5929: SP#52 completed. 3/3/15: start and finish dates corrected (was start on Jan-00, ends on Jan-02) / WI rapporteur e-mail: farooq.bari@att.com
- 5930: SP#52 completed / WI rapporteur e-mail: Li Lianyuan (lilianyuan@chinamobile.com), Liu Hong (liuhongyfw@chinamobile.com)
- 5931: SP#54 completed. Study on "reverse direction" from UTRAN/GERAN to E-UTRAN/HSPA (Rel-8 SRVCC was in the other direction E-UTRAN/HSPA to GERAN/UTRAN) / WI rapporteur e-mail: delphin.barankanira@orange-ftgroup.com
- 5932: SP#54 completed. Linked to Rel-11 OSCAR (Optimized Service Charging and Allocation of ResourcES in CP-150IMS whilst Roaming) UID_490032. Related to LBO/home routing decision / WI rapporteur e-mail: michele.zarri@telekom.com
- 5933: SP#55 completed / WI rapporteur e-mail: karl.norrman@ericsson.com
- 5934: SP#56 completed. SP#55 TR 33.914v200 approved (converted 33.804). Study reuse of non-UICC credentials (in particular SIP Digest) to provide security for access to applications. Provide reference material for IMS based non-UICC based SSO to applications / WI rapporteur e-mail: Silke.Holtmanns@nokia.com
- 5935: SP#56 completed. Extends Rel-10 work on 3D video formats UID_480044 Improved Video Coding Support for PSS and MBMS / WI rapporteur e-mail: gilles.teniou@orange-ftgroup.com
- 5936: SP#57 completed. TR 32.833v200 for Approval / WI rapporteur e-mail: Jörg Schmidt (J.Schmidt@nsn.com)
- 5937: SP#54 completed / WI rapporteur e-mail: Nick Mazzarella (njmazzarella@alcatel-lucent.com)
- 5938: SP#54 completed. Triggered by Rel-10 UID_430044 TR 32.826 Study on Energy Savings Management (FS_OAM_ESM) and UID_470037 OAM aspects of Energy Saving in Radio Networks (OAM-ES) / WI rapporteur e-mail: clemens.suerbaum@nsn.com
- 5939: CP#52 completed. Linked to SA5 UID_430044 (FS_OAM-ESM) & UID_470037 (OAM-ES), RAN3 UID_470015 (FS_Energy_LTE), RAN1 UID_460016 (FS_Energy_UMTS) / WI rapporteur e-mail: gottfried.punz@nw.neclab.eu
- 5940: CP#58 completed. Continue work in Rel-11 especially to cover handling of Idle mode Signalling Reduction (ISR). Linked to SA2 UID_490036 Study on Core Network Overload solutions / WI rapporteur e-mail: lu.fei1@zte.com.cn
- 5941: GP#53 completed (03/12). GP#46 approved WID. / WI rapporteur e-mail: marten.sundberg@ericsson.com
- 5942: RP#53 completed / WI rapporteur e-mail: bruno.clerckx@samsung.com
- 5943: RP#53 completed. Studied coexistence scenario of LTE and Industrial, Scientific and Medical (ISM) Radio within the same device working in adjacent frequencies / WI rapporteur e-mail: Zhenping Hu (huzhenping@chinamobile.com)
- 5944: RP#57 completed. TR 36.839 v100 for Information & Approval / WI rapporteur e-mail: sudeep.palat@alcatel-lucent.com
- 5945: RP#54 completed / WI rapporteur e-mail: federico.boccardi@alcatel-lucent.com
- 5946: RP#56 completed. TR 36.828 for Information and Approval / WI rapporteur e-mail: Zukang Shen (shenzukang@catt.cn)
- 5947: RP#56 completed. TR 36.824 v200 for Approval / WI rapporteur e-mail: Peng Chen (chenpeng@ctbri.com.cn)
- 5948: RP#55 completed. TR 36.829 v100 for Information + Approval / WI rapporteur e-mail: Yuta Sagae
- 5949: RP#57 completed / WI rapporteur e-mail: Xudong An (anxudong@emcite.com)
- 5950: RP#55 completed. TR 37.976 v200 for Approval / WI rapporteur e-mail: Tim.frost@vodafone.com
- 5951: RP#57 completed. TR 37.806 v200 for Approval / WI rapporteur e-mail: christian.bergljung@ericsson.com
- 5952: RP#53 completed. TR 37.868v100 for Approval (No WID change: RAN overload only). Triggered by TR 22.868 Study on Facilitating Machine to Machine Communication in GSM and UMTS (M2M) UID_7027 and Rel-10 NIMTC UID_410030 / WI rapporteur e-mail: Jeff Gao (gaoyq@huawei.com)
- 5953: RP#54 completed / WI rapporteur e-mail: ron.borsato@spirent.com
- 5954: RP#56 completed. TR 37.803 v200 for Approval / WI rapporteur e-mail: Martin.Warner@alcatel-lucent.com
- 5955: RP#56 completed. Impacts TR 37.804 Study on UMTS/LTE in 900 MHz band (Japan, Korea) UID_520018 / WI rapporteur e-mail: Koo Yeon Sang (yskoo@lguplus.co.kr)
- 5956: RP#56 completed. Updated WID RP-111751=>RP-120617. TR 37.804 v100 for Information and Approval. Linked to Study on Interference analysis between 800~900 MHz bands UID_510038 / WI rapporteur e-mail: Masahiro Fujii (fujiima@nttdocomo.co.jp)
- 5957: RP#53 completed (1-step Approval) / WI rapporteur e-mail: Sharad Sambhwani
- 5958: RP#53 completed / WI rapporteur e-mail: karri.ranta-aho@nsn.com
- 5959: RP#57 completed / WI rapporteur e-mail: petri.j.vasenkari@nokia.com
- 5960: RP#57 completed. TR 25.874 v100 for Information & Approval / WI rapporteur e-mail: limei.wei@td-tech.com
- 5961: RP#56 stopped. RP-120856 discussion: most content moved to Rel-11 Coordinated Multi-Point Operation for LTE Uplink (COMP_LTE_UL) and RAN1 has no time to look at it / WI rapporteur e-mail: Yongxing Zhou
- 5962: -

| ID | WBS | Task | Duration | Start | Finish | Complete | Baseline start | Baseline finish | Baseline duration | Constraint | Resources | Work | Actual work | Acronym | PCG approved | WI rapporteur name | WI rapporteur e-mail | Release | TSG approved | MCC resp | Special Focus Doc | Acronym_3GU_Export | PCG stopped | TSG stopped | Status Report |
| --- | --- | --- | --- | --- | --- | --- | --- | --- | --- | --- | --- | --- | --- | --- | --- | --- | --- | --- | --- | --- | --- | --- | --- | --- | --- |
| 5963 | 1936 | **Enhancements for Multimedia Priority Service** | 1311d? | 2006-03-13 A | 2011-03-18 A | 100% | 2006-03-13 | 2011-03-18 | 1311d? |  | S1; S2; C4; C3; C1 | 72120h | 72120h | eMPS | 21 | Telcordia | jgarraha@telcordia.com | Rel-10 | 39 | Alain | Public Safety (I-A) | eMPS |  |  |  |
| 5964 | 1936.1 | Stage 1 on enhancements for Multimedia Priority Service | 584d? | 2006-03-13 A | 2008-06-05 A | 100% | 2006-03-13 | 2008-06-05 | 584d? | start no earlier than 2006-03-12 | S1 | 4672h | 4672h | ePRIOR-St1 | 21 | Telcordia | jgarraha@telcordia.com | Rel-10 | 39 | Alain | Public Safety (I-A) | ePRIOR |  |  |  |
| 5965 | 1936.2 | **Stage 2 on enhancements for Multimedia Priority Service** | 206d? | 2009-12-10 A | 2010-09-23 A | 100% | 2009-12-10 | 2010-09-23 | 206d? |  | S2 | 6592h | 6592h | ePRIOR-St2 | 24 | Telcordia, NTT DoCoMo | Vijay Varma, Katsutoshi Nishida | Rel-10 | 46 | Maurice | Public Safety (I-A) |  |  |  |  |
| 5966 | 1936.2.1 | Stage 2 on eMPS for CSFB | 206d? | 2009-12-10 A | 2010-09-23 A | 100% | 2009-12-10 | 2010-09-23 | 206d? | finish no earlier than 2010-09-24 | S2 | 1648h | 1648h | ePRIOR-St2 | 24 | Telcordia, NTT DoCoMo | Vijay Varma, Katsutoshi Nishida | Rel-10 | 46 | Maurice | Public Safety (I-A) |  |  |  |  |
| 5967 | 1936.2.2 | Stage 2 on eMPS for EPS Bearer Service | 206d? | 2009-12-10 A | 2010-09-23 A | 100% | 2009-12-10 | 2010-09-23 | 206d? | finish no earlier than 2010-12-09 | S2 | 1648h | 1648h | ePRIOR-St2 | 24 | Telcordia, NTT DoCoMo | Vijay Varma, Katsutoshi Nishida | Rel-10 | 46 | Maurice | Public Safety (I-A) |  |  |  |  |
| 5968 | 1936.2.3 | Stage 2 on eMPS for IMS Aspects | 206d? | 2009-12-10 A | 2010-09-23 A | 100% | 2009-12-10 | 2010-09-23 | 206d? | finish no earlier than 2010-12-09 | S2 | 1648h | 1648h | ePRIOR-St2 | 24 | Telcordia, NTT DoCoMo | Vijay Varma, Katsutoshi Nishida | Rel-10 | 46 | Maurice | Public Safety (I-A) |  |  |  |  |
| 5969 | 1936.3 | Deleted - TR 23.854 on Stage 2 on enhancements for Multimedia Priority Service | 266d? | 2009-12-10 A | 2010-12-16 A | 100% | 2009-12-10 | 2010-12-16 | 266d? | finish no earlier than 2011-03-17 | S2 | 2128h | 2128h |  | 24 | Telcordia, NTT DoCoMo | Vijay Varma, Katsutoshi Nishida | Rel-10 | 46 | Maurice | Public Safety (I-A) |  | PCG-27 | SP-50 |  |
| 5970 | 1936.4 | **Stage 3 on enhancements for Multimedia Priority Service** | 131d? | 2010-09-17 A | 2011-03-18 A | 100% | 2010-09-17 | 2011-03-18 | 131d? |  | C4; C3; C1 | 6288h | 6288h | eMPS-CN | 25 | Ericsson | Philip.hodges@ericsson.com | Rel-10 | 49 | Kimmo | Public Safety (I-A) | eMPS-CN |  |  |  |
| 5971 | 1936.4.1 | CT4 part on Stage 3 on enhancements for Multimedia Priority Service | 131d? | 2010-09-17 A | 2011-03-18 A | 100% | 2010-09-17 | 2011-03-18 | 131d? | start no earlier than 2010-09-17 | C4 | 1048h | 1048h | eMPS-CN | 25 | Ericsson | Philip.hodges@ericsson.com | Rel-10 | 49 | Kimmo | Public Safety (I-A) |  |  |  |  |
| 5972 | 1936.4.2 | CT3 part on Stage 3 on enhancements for Multimedia Priority Service | 131d? | 2010-09-17 A | 2011-03-18 A | 100% | 2010-09-17 | 2011-03-18 | 131d? | start no earlier than 2010-09-17 | C3 | 1048h | 1048h | eMPS-CN | 25 | Ericsson | Philip.hodges@ericsson.com | Rel-10 | 49 | Adrian | Public Safety (I-A) |  |  |  |  |
| 5973 | 1936.4.3 | CT1 part on Stage 3 on enhancements for Multimedia Priority Service | 131d? | 2010-09-17 A | 2011-03-18 A | 100% | 2010-09-17 | 2011-03-18 | 131d? | start no earlier than 2010-09-17 | C1 | 1048h | 1048h | eMPS-CN | 25 | Ericsson | Philip.hodges@ericsson.com | Rel-10 | 49 | Frederic | Public Safety (I-A) |  |  |  |  |
| 5974 | 1937 | **Network Improvements for Machine-Type Communications** | 1365d? | 2008-09-18 A | 2013-11-22 A | 100% | 2008-09-18 | 2013-11-22 | 1365d? |  | S1; S2; S5; C1; C4; C6; G2; R2; R3; R5; G3new | 149017h | 149017h | NIMTC | 21 | KPN | toon.norp@tno.nl | Rel-10 | 41 | Alain | MTC, M2M | NIMTC |  |  |  |
| 5975 | 1937.1 | Stage 1 for Network Improvements for Machine-Type Communications | 397d? | 2008-09-18 A | 2010-03-25 A | 100% | 2008-09-18 | 2010-03-25 | 397d? | finish no earlier than 2009-12-10 | S1 | 3176h | 3176h | NIMTC | 21 | KPN | toon.norp@tno.nl | Rel-10 | 41 | Alain | MTC, M2M |  |  |  |  |
| 5976 | 1937.2 | Deleted - TR on Stage 2 for Network Improvements for Machine-Type Communications | 321d? | 2009-09-24 A | 2010-12-16 A | 100% | 2009-09-24 | 2010-12-16 | 321d? | finish no earlier than 2010-11-30 | S2 | 2568h | 2568h | NIMTC | 23 | Samsung | erik.guttman@partner.samsung.com | Rel-10 | 45 | Maurice | MTC, M2M |  | PCG-26 | SP-50 |  |
| 5977 | 1937.3 | Stage 2 for Network Improvements for Machine-Type Communications | 19d? | 2010-08-30 A | 2010-09-23 A | 100% | 2010-08-30 | 2010-09-23 | 19d? | finish no earlier than 2010-09-17 | S2 | 152h | 152h | NIMTC | 23 | Samsung | erik.guttman@partner.samsung.com | Rel-10 | 45 | Maurice | MTC, M2M |  |  |  |  |
| 5978 | 1937.4 | Deleted - Security for Network Improvements for Machine-Type Communications | 193.15d? | 2009-12-10 A | 2010-09-23 A | 100% | 2009-12-10 | 2010-09-23 | 193.15d? | finish no earlier than 2010-09-23 | S3 | 1545.2h | 1545.2h | NIMTC | 24 | Samsung | Rajavelsamy R (rajvel@samsung.com) | Rel-10 | 46 | Mirko | MTC, M2M |  | PCG-25 | SP-49 |  |
| 5979 | 1937.5 | Charging for Network Improvements for Machine-Type Communication | 3d? | 2011-03-21 A | 2011-03-23 A | 100% | 2011-03-21 | 2011-03-23 | 3d? | start no earlier than 2011-03-21 | S5 | 24h | 24h | NIMTC-CH | 26 | Ericsson | patrik.teppo@@ericsson.com | Rel-10 | 51 | Mirko | MTC, M2M | NIMTC-CH |  |  |  |
| 5980 | 1937.6 | **CN part of Stage 3 for Network Improvements for Machine-Type Communications** | 261d? | 2010-06-04 A | 2011-06-03 A | 100% | 2010-06-04 | 2011-06-03 | 261d? |  | C1; C4; C6 | 12976h | 12976h | NIMTC-CN | 25 | Ericsson | mikael.wass@ericsson.com | Rel-10 | 48 | Frederic | MTC, M2M | NIMTC-CN |  |  |  |
| 5981 | 1937.6.1 | CT1 part of Stage 3 for Network Improvements for Machine-Type Communications | 261d? | 2010-06-04 A | 2011-06-03 A | 100% | 2010-06-04 | 2011-06-03 | 261d? | finish no earlier than 2011-06-03 | C1 | 2088h | 2088h | NIMTC-CN | 25 | Ericsson | mikael.wass@ericsson.com | Rel-10 | 48 | Frederic | MTC, M2M |  |  |  |  |
| 5982 | 1937.6.2 | Deleted - CT3 part of Stage 3 for Network Improvements for Machine-Type Communications | 261d? | 2010-06-04 A | 2011-06-03 A | 100% | 2010-06-04 | 2011-06-03 | 261d? | finish no earlier than 2010-12-10 | C3 | 2088h | 2088h | NIMTC-CN | 25 | Ericsson | mikael.wass@ericsson.com | Rel-10 | 48 | Adrian | MTC, M2M |  | PCG-27 | CP-52 |  |
| 5983 | 1937.6.3 | CT4 part of Stage 3 for Network Improvements for Machine-Type Communications | 261d? | 2010-06-04 A | 2011-06-03 A | 100% | 2010-06-04 | 2011-06-03 | 261d? | finish no earlier than 2011-03-18 | C4 | 2088h | 2088h | NIMTC-CN | 25 | Ericsson | mikael.wass@ericsson.com | Rel-10 | 48 | Kimmo | MTC, M2M |  |  |  |  |
| 5984 | 1937.6.4 | CT6 part of Stage 3 for Network Improvements for Machine-Type Communications | 56d? | 2011-03-18 A | 2011-06-03 A | 100% | 2011-03-18 | 2011-06-03 | 56d? | finish no earlier than 2011-06-03 | C6 | 448h | 448h | NIMTC-CN | 26 | Sagem-Orga | heiko.kruse@sagem-orga.com | Rel-10 | 51 | Xavier | MTC, M2M |  |  |  |  |
| 5985 | 1937.7 | GERAN part of Network Improvements for Machine-Type Communications (Stage 3) | 261d? | 2010-09-03 A | 2011-09-02 A | 100% | 2010-09-03 | 2011-09-02 | 261d? | finish no earlier than 2011-09-02 | G2 | 2088h | 2088h | NIMTC | 25 | Vodafone, Ericsson | leo.patanapongpibul@vodafone.com, john.diachina@ericsson.com | Rel-10 | 47 | Gert | MTC, M2M |  |  |  |  |
| 5986 | 1937.8 | MS Conformance Test Aspects for GERAN - Network Improvements for Machine-Type Communications | 333d? | 2012-08-27 A | 2013-11-22 A | 100% | 2012-08-27 | 2013-11-22 | 333d? | finish no earlier than 2013-11-22 | G3new | 2656h | 2656h | NIMTC_GERAN-MSTest | 29 | ST-Ericsson | hakan.e.grunditz@stericsson.com | Rel-10 | 55 | Ingbert | MTC, M2M | NIMTC_GERAN-MSTest |  |  |  |
| 5987 | 1937.9 | RAN mechanisms to avoid CN overload due to Machine-Type Communications | 131d? | 2010-09-17 A | 2011-03-18 A | 100% | 2010-09-17 | 2011-03-18 | 131d? | finish no earlier than 2011-03-18 | R2; R3 | 2096h | 2096h | NIMTC-RAN_overload | 25 | Huawei | Jeff Gao (gaoyq@huawei.com) | Rel-10 | 49 | Yong-Jun | MTC, M2M | NIMTC-RAN_overload |  |  | RP-110063 |
| 5988 | 1937.10 | UE Conformance Test Aspects - Network Improvements for Machine-Type Communications | 202d? | 2012-09-11 A | 2013-06-14 A | 100% | 2012-09-11 | 2013-06-14 | 202d? | finish no earlier than 2013-06-14 | R5 | 1616h | 1616h | NIMTC-UEConTest | 29 | Ericsson | calle.hagenfeldt@ericsson.com | Rel-10 | 57 | Ingbert | MTC, M2M | NIMTC-UEConTest |  |  | RP-130465 |

Notes:
- 5963: CP#51 completed. SP#49 moved Stage 1 from Rel-9 & Completed Stage 2. SP#40 Stage 1 completed. Continuation of Rel-8 Feature PRIOR (UID_340044)
- 5964: 22/01: acronym modified / Impacted TSs and TRs: 22.153; 22.278
- 5965: 22/01: acronym modified
- 5966: 22/01: acronym modified / Impacted TSs and TRs: 23.002; 23.203; 23.221; 23.228; 23.272; 23.401
- 5967: 22/01: acronym modified / Impacted TSs and TRs: 23.002; 23.203; 23.221; 23.228; 23.272; 23.401
- 5968: 22/01: acronym modified / Impacted TSs and TRs: 23.002; 23.203; 23.221; 23.228; 23.272; 23.401
- 5969: SP#49 TR 23.854 v100 for Information. SP#50 moved to Rel-11 SRVCC aspect of enhancements for Multimedia Priority Service UID_480135 (place holder for solution alternatives and agreed functions to be reflected in affected existing TS) / Impacted TSs and TRs: new 23.854
- 5970: CP#51 completed / Impacted TSs and TRs: Stage 3
- 5971: CP#51 completed / Impacted TSs and TRs: 23.008; 29.002; 29.228; 29.229; 29.272; 29.274; 29.277; 29.328; 29.329
- 5972: CP#51 completed / Impacted TSs and TRs: 29.212; 29.213; 29.214
- 5973: CP#51 completed / Impacted TSs and TRs: 24.008; 24.229; 24.301
- 5974: Triggered by Rel-8 UID_7027 Study on Facilitating Machine to Machine Communication in GSM and UMTS (FS_M2M) TR 22.868
- 5975: SP#47 completed / Impacted TSs and TRs: 22.011; New 22.368
- 5976: SP#50 updated WID SP-090832=>SP-100863 (TR 23.888 not submitted for approval to conclude Rel-10 NIMTC as it will continue to serve as basis for Rel-11 SIMTC work item) / Impacted TSs and TRs: New 23.888
- 5977: SP#49 completed / Impacted TSs and TRs: 23.060; 23.236; 23.401
- 5978: SP#49 stopped (activity transferred to Rel-11 Feature SIMTC under UID_490028 "TR on Security aspects of Machine-Type Communications". / Impacted TSs and TRs: New 33.868
- 5979: SP#51 completed / Impacted TSs and TRs: 32.251; 32.298; 32.299
- 5980: CP#52 completed / Impacted TSs and TRs: Stage 3
- 5981: CP#52 completed / Impacted TSs and TRs: 23.122; 24.008; 24.301; New 24.368
- 5982: CP#52 stopped (SA2 decided to move impact from CT3 to CT4). Updated WID CP-110147=>CP-110442 (no CT3 impact) / Impacted TSs and TRs: 29.212; 29.213; 29.215
- 5983: CP#52 completed / Impacted TSs and TRs: 23.003; 23.008; 29.002; 29.060; 29.230; 29.272; 29.274; 29.275; 29.282
- 5984: CP#52 completed / Impacted TSs and TRs: 31.102
- 5985: GP#51 completed. GP#47 approved WID / Impacted TSs and TRs: 44.018; 44.060
- 5986: GP#60 completed. GP#55 approved WID. Testing for CT1 part of Stage 3 for NIMTC UID_480105, GERAN part of NIMTC (Stage 3) UID_490003 / Impacted TSs and TRs: 51.010-1; 51.010-2
- 5987: RP#51 completed / Impacted TSs and TRs: UTRA; LTE 25.331; 25.413; 36.331; 36.413
- 5988: RP#60 completed. Testing for CT1 part of Stage 3 UID_480105, RAN mechanisms to avoid CN overload due to MTC UID_490024 / Impacted TSs and TRs: 34.123-1; 34.123-2; 34.123-3; 36.523-1; 36.523-2; 36.523-3

| ID | WBS | Task | Duration | Start | Finish | Complete | Baseline start | Baseline finish | Baseline duration | Constraint | Resources | Work | Actual work | Acronym | PCG approved | WI rapporteur name | Release | TSG approved | MCC resp | Acronym_3GU_Export | Special Focus Doc |
| --- | --- | --- | --- | --- | --- | --- | --- | --- | --- | --- | --- | --- | --- | --- | --- | --- | --- | --- | --- | --- | --- |
| 5989 | 1938 | **Multi Access PDN Connectivity** | 527d? | 2009-03-13 A | 2011-03-18 A | 100% | 2009-03-13 | 2011-03-18 | 527d? |  | S2; C4; C1; C3 | 23680h | 23680h | MAPCON | 22 | Telecom Italia | Rel-10 | 43 | Maurice | MAPCON |  |
| 5990 | 1938.1 | Stage 2 for Multi Access PDN Connectivity | 401d? | 2009-03-13 A | 2010-09-23 A | 100% | 2009-03-13 | 2010-09-23 | 401d? |  | S2 | 3208h | 3208h | MAPCON | 22 | Telecom Italia | Rel-10 | 43 | Maurice |  |  |
| 5991 | 1938.2 | **CT aspects of Multi Access PDN Connectivity** | 90d? | 2010-11-15 A | 2011-03-18 A | 100% | 2010-11-15 | 2011-03-18 | 90d? |  | C4; C1; C3 | 3608h | 3608h | MAPCON-St3 | 26 | ZTE | Rel-10 | 50 | Kimmo | MAPCON-St3 |  |
| 5992 | 1938.2.1 | CT4 aspects of Multi Access PDN Connectivity | 20d? | 2010-11-15 A | 2010-12-10 A | 100% | 2010-11-15 | 2010-12-10 | 20d? | start no earlier than 2010-12-10 | C4 | 160h | 160h | MAPCON-St3 | 26 | ZTE | Rel-10 | 50 | Kimmo |  |  |
| 5993 | 1938.2.2 | CT1 aspects of Multi Access PDN Connectivity | 71d? | 2010-12-10 A | 2011-03-18 A | 100% | 2010-12-10 | 2011-03-18 | 71d? | start no earlier than 2010-12-10 | C1 | 568h | 568h | MAPCON-St3 | 26 | ZTE | Rel-10 | 50 | Frederic |  |  |
| 5994 | 1938.2.3 | CT3 aspects of Multi Access PDN Connectivity | 90d? | 2010-11-15 A | 2011-03-18 A | 100% | 2010-11-15 | 2011-03-18 | 90d? | finish no earlier than 2011-03-18 | C3 | 720h | 720h | MAPCON-St3 | 26 | ZTE | Rel-10 | 50 | Adrian |  |  |
| 5995 | 1939 | **IMS Service Continuity – Inter Device Transfer enhancements** | 924d? | 2009-06-04 A | 2012-12-07 A | 100% | 2009-06-04 | 2012-12-07 | 924d? |  | S1; S2; C1; IETF | 41168h | 41168h | IMS_SC_eIDT | 23 | Huawei | Rel-10 | 44 | Alain | IMS_SC_eIDT |  |
| 5996 | 1939.1 | Stage 1 - IMS Service Continuity – Inter Device Transfer enhancements | 211d? | 2009-06-04 A | 2010-03-25 A | 100% | 2009-06-04 | 2010-03-25 | 211d? | finish no earlier than 2010-03-25 | S1 | 1688h | 1688h | IMS_SC_eIDT | 23 | Huawei | Rel-10 | 44 | Alain |  |  |
| 5997 | 1939.2 | Stage 2 - IMS Inter-UE Transfer enhancements | 261d? | 2009-09-24 A | 2010-09-23 A | 100% | 2009-09-24 | 2010-09-23 | 261d? | finish no earlier than 2010-09-23 | S2 | 2088h | 2088h | IMS_SC_eIDT | 23 | Huawei | Rel-10 | 45 | Maurice |  |  |
| 5998 | 1939.3 | Stage 3 - IMS Inter-UE Transfer enhancements | 261d? | 2010-03-19 A | 2011-03-18 A | 100% | 2010-03-19 | 2011-03-18 | 261d? | start no earlier than 2010-03-19 | C1 | 2088h | 2088h | IMS_SC_eIDT | 24 | Huawei | Rel-10 | 47 | Frederic |  |  |
| 5999 | 1939.4 | (IETF) Stage 3 - IMS Inter-UE Transfer enhancements | 717d? | 2010-03-19 A | 2012-12-07 A | 100% | 2010-03-19 | 2012-12-07 | 717d? | finish no earlier than 2012-12-04 | C1-IETF | 5736h | 5736h | IMS_SC_eIDT | 27 | christer.holmberg@ericsson.com | Rel-10 | 52 | Frederic |  |  |
| 6000 | 1940 | **IP-Short-Message-Gateway enhancements for CPM-SMS Interworking** | 257d? | 2009-09-24 A | 2010-09-17 A | 100% | 2009-09-24 | 2010-09-17 | 257d? |  | S1; S2; C3 | 9904.8h | 9904.8h | CPM-SMS | 23 | China Mobile | Rel-10 | 45 | Alain | CPM-SMS |  |
| 6001 | 1940.1 | Stage 1 for CPM-SMS | 131d? | 2009-09-24 A | 2010-03-25 A | 100% | 2009-09-24 | 2010-03-25 | 131d? | finish no earlier than 2010-03-25 | S1 | 1048h | 1048h | CPM-SMS | 23 | China Mobile | Rel-10 | 45 | Alain |  |  |
| 6002 | 1940.2 | Stage 2 for CPM-SMS | 130.1d? | 2009-09-24 A | 2010-03-25 A | 100% | 2009-09-24 | 2010-03-25 | 130.1d? | finish no earlier than 2010-03-25 | S2 | 1040.8h | 1040.8h | CPM-SMS | 23 | Orange | Rel-10 | 45 | Maurice |  |  |
| 6003 | 1940.3 | Stage 3 for IP-Short-Message-Gateway enhancements for CPM-SMS Interworking | 206d? | 2009-12-04 A | 2010-09-17 A | 100% | 2009-12-04 | 2010-09-17 | 206d? | finish no earlier than 2010-09-17 | C3 | 1648h | 1648h | CPM-SMS | 24 | Ericsson | Rel-10 | 46 | Adrian |  |  |
| 6004 | 1941 | **Completion of Communications on Not Logged-in** | 387d? | 2009-09-24 A | 2011-03-18 A | 100% | 2009-09-24 | 2011-03-18 | 387d? |  | S1; C1; C3 | 11992h | 11992h | CCNL | 23 | Deutsche Telekom | Rel-10 | 45 | Alain | CCNL |  |
| 6005 | 1941.1 | Stage 1 for Completion of Communications on Not Logged-in | 1d? | 2009-09-24 A | 2009-09-24 A | 100% | 2009-09-24 | 2009-09-24 | 1d? | start no earlier than 2009-09-24 | S1 | 8h | 8h | CCNL | 23 | Deutsche Telekom | Rel-10 | 45 | Alain |  |  |
| 6006 | 1941.2 | CT1 part of Stage 3 for Completion of Communications on Not Logged-in | 261d? | 2010-03-19 A | 2011-03-18 A | 100% | 2010-03-19 | 2011-03-18 | 261d? | finish no earlier than 2011-03-18 | C1 | 2088h | 2088h | CCNL | 24 | Deutsche Telekom | Rel-10 | 47 | Frederic |  |  |
| 6007 | 1941.3 | CT3 part of Stage 3 for Completion of Communications on Not Logged-in | 76d? | 2010-06-04 A | 2010-09-17 A | 100% | 2010-06-04 | 2010-09-17 | 76d? | finish no earlier than 2010-09-17 | C3 | 608h | 608h | CCNL | 25 | Deutsche Telekom | Rel-10 | 48 | Adrian |  |  |
| 6008 | 1942 | **Local IP Access and Selected Internet IP Traffic Offload** | 390d? | 2009-09-24 A | 2011-03-23 A | 100% | 2009-09-24 | 2011-03-23 | 390d? |  | S2; S1; S3; S5; C4; C1 | 66128h | 66128h | LIPA_SIPTO | 23 | Huawei, China Mobile | Rel-10 | 45 | Maurice | LIPA_SIPTO | HNB |
| 6009 | 1942.1 | Stage 1 for Local IP Access and Selected Internet IP Traffic Offload | 131d? | 2009-09-24 A | 2010-03-25 A | 100% | 2009-09-24 | 2010-03-25 | 131d? | finish no earlier than 2010-03-25 | S1 | 1048h | 1048h | LIPA_SIPTO | 23 | Huawei, China Mobile | Rel-10 | 45 | Alain |  | HNB |
| 6010 | 1942.2 | TR on Local IP Access and Selected Internet IP Traffic Offload | 387d? | 2009-09-24 A | 2011-03-18 A | 100% | 2009-09-24 | 2011-03-18 | 387d? | finish no earlier than 2011-03-18 | S2 | 3096h | 3096h | LIPA_SIPTO | 23 | Huawei, China Mobile | Rel-10 | 45 | Maurice |  | HNB |
| 6011 | 1942.3 | Security for Local IP Access and Selected Internet IP Traffic Offload | 261d? | 2009-09-24 A | 2010-09-23 A | 100% | 2009-09-24 | 2010-09-23 | 261d? | finish no earlier than 2010-09-23 | S3 | 2088h | 2088h | LIPA_SIPTO | 23 | Huawei, Qualcomm | Rel-10 | 45 | Mirko |  | HNB |
| 6012 | 1942.4 | OAM&P for Local IP Access and Selected Internet IP Traffic Offload | 390d? | 2009-09-24 A | 2011-03-23 A | 100% | 2009-09-24 | 2011-03-23 | 390d? | finish no earlier than 2011-03-23 | S5 | 3120h | 3120h | LIPA_SIPTO | 23 | Huawei, China Mobile | Rel-10 | 45 | Mirko |  | HNB |
| 6013 | 1942.5 | Charging for Local IP Access and Selected Internet IP Traffic Offload | 335d? | 2009-12-10 A | 2011-03-23 A | 100% | 2009-12-10 | 2011-03-23 | 335d? | finish no earlier than 2011-03-23 | S5 | 2680h | 2680h | LIPA_SIPTO | 24 | Huawei, China Mobile | Rel-10 | 46 | Mirko |  | HNB |

Notes:
- 5989: CP#51 completed. SP#49 Stage 2 completed. Triggered by TR 23.861 UID_410043 FS_MAPIM. Stage 1 in Rel-9 22.278 (6.2 - IP session control) / WI rapporteur e-mail: ivano.guardini@telecomitalia.it
- 5990: SP#49 completed. Triggered by TR 23.861 UID_410043 FS_MAPIM. Stage 1 in Rel-9 22.278 (6.2 - IP session control) / Impacted TSs and TRs: 23.237; 23.401; 23.402 / WI rapporteur e-mail: ivano.guardini@telecomitalia.it
- 5991: CP#51 completed / WI rapporteur e-mail: Xingyue (Joy) Zhou (zhou.xingyue@zte.com.cn)
- 5992: CP#50 completed / Impacted TSs and TRs: 29.273; 29.272; 29.002; 23.008 / WI rapporteur e-mail: Xingyue (Joy) Zhou (zhou.xingyue@zte.com.cn)
- 5993: CP#51 completed / Impacted TSs and TRs: 24.302; 24.312 / WI rapporteur e-mail: Xingyue (Joy) Zhou (zhou.xingyue@zte.com.cn)
- 5994: CP#51 completed / Impacted TSs and TRs: 29.215 / WI rapporteur e-mail: Xingyue (Joy) Zhou (zhou.xingyue@zte.com.cn)
- 5995: CP#51 completed. SP#47 Stage 1 completed. Rel-9 set Inter-Device Transfer requirements UID_410033 (IMS_SCC-IDT). Adds IDT scenarios and requirements / WI rapporteur e-mail: Amar Deol (adeol@huawei.com)
- 5996: SP#47 completed / Impacted TSs and TRs: 22.228 / WI rapporteur e-mail: Amar Deol (adeol@huawei.com)
- 5997: SP#49 completed / Impacted TSs and TRs: 23.237; 23.292; new 23.831 / WI rapporteur e-mail: Lee Valerius (lvalerius@huawei.com)
- 5998: CP#51 completed. WID updated CP-100334=>CP-110285 / Impacted TSs and TRs: 24.216; 24.229; 24.237; new (24.837; 24.337) / WI rapporteur e-mail: georg.mayer@huawei.com
- 5999: CP#58 completed / Impacted TSs and TRs: RFC 6809 (was draft-ietf-sipcore-proxy-feature) / WI rapporteur e-mail: christer.holmberg@ericsson.com
- 6000: CP#49 completed. SP#47 Stage 1 completed. IP-SM-GW enhancements for interworking with OMA CPM / WI rapporteur e-mail: Qing Huang (huangqing@chinamobile.com)
- 6001: SP#47 completed. External requirements (Stage 1 in OMA-RD-CPM-V1_0-20090310-C) / Impacted TSs and TRs: 22.340 / WI rapporteur e-mail: Qing Huang
- 6002: SP#47 completed / Impacted TSs and TRs: 23.204; new 23.824 / WI rapporteur e-mail: antoine.mouquet@orange-ftgroup.com
- 6003: CP#49 completed. Linked to Rel-8 UID_340031 Service-Level Interworking for Messaging Services (MESSIW) 23.204 / Impacted TSs and TRs: 29.311 / WI rapporteur e-mail: Jan Holm
- 6004: CP#51 completed. SP#45 Stage 1 completed / WI rapporteur e-mail: Kurt Bischinger
- 6005: SP#45 completed / Impacted TSs and TRs: 22.173 CR#0056r1 / WI rapporteur e-mail: Kurt Bischinger
- 6006: CP#51 completed / Impacted TSs and TRs: 24.173; 24.642 / WI rapporteur e-mail: martin.huelsemann@telekom.de
- 6007: CP#49 completed / Impacted TSs and TRs: 29.165 / WI rapporteur e-mail: martin.huelsemann@telekom.de
- 6008: TSG#51 completed. Updated WID SP-100696=>SP-110131. SP#49 Stage 2 & Security completed. UID_400035 Enhanced Home NodeB/eNodeB (EHNB) formerly covered Local IP Access to Internet and Local access to Home Network from the Home NodeB/eNodeB / WI rapporteur e-mail: patrice.hede@huawei.com, Tao Sun (suntao@chinamobile.com)
- 6009: SP#47 completed / Impacted TSs and TRs: 22.101; 22.220 / WI rapporteur e-mail: Amar Deol (adeolf@huawei.com), Gang Li (ligangyf@chinamobile.com)
- 6010: SP#51 completed. TR 23.829 for Approval / Impacted TSs and TRs: New 23.829 / WI rapporteur e-mail: patrice.hede@huawei.com, Tao Sun (suntao@chinamobile.com)
- 6011: SP#49 completed / Impacted TSs and TRs: 33.102; 33.107; 33.108; 33.320; 33.401 / WI rapporteur e-mail: Marcus Wong (mwong@huawei.com), Brian Rosenberg (bmr@qualcomm.com)
- 6012: SP#51 completed. Updated WID SP-100696=>SP-110131 / Impacted TSs and TRs: 32.581; 32.582; 32.584; 32.591; 32.592; 32.642; 32.646; 32.772; 32.782 / WI rapporteur e-mail: Zou Lan (zlan@huawei.com), Chen Gang (chengang@chinamobile.com)
- 6013: SP#51 completed. Updated WID SP-100696=>SP-110131 / Impacted TSs and TRs: 32.251 / WI rapporteur e-mail: shan.mingjun@huawei.com, Ai Chen (chenai@chinamobile.com)

| ID | WBS | Task | Duration | Start | Finish | Complete | Baseline start | Baseline finish | Baseline duration | Constraint | Resources | Work | Actual work | Acronym | PCG approved | WI rapporteur name | WI rapporteur e-mail | Release | TSG approved | MCC resp | Special Focus Doc | Acronym_3GU_Export |
| --- | --- | --- | --- | --- | --- | --- | --- | --- | --- | --- | --- | --- | --- | --- | --- | --- | --- | --- | --- | --- | --- | --- |
| 6014 | 1942.6 | **Stage 2/3 for Local IP Access** | 387d? | 2009-09-24 A | 2011-03-18 A | 100% | 2009-09-24 | 2011-03-18 | 387d? |  | S2; C4; C1 | 17968h | 17968h | LIPA | 23 | Huawei, China Mobile | patrice.hede@huawei.com, Tao Sun (suntao@chinamobile.com) | Rel-10 | 45 | Maurice | HNB | LIPA |
| 6015 | 1942.6.1 | Stage 2 for Local IP Access | 261d? | 2009-09-24 A | 2010-09-23 A | 100% | 2009-09-24 | 2010-09-23 | 261d? | finish no earlier than 2010-08-10 | S2 | 2088h | 2088h | LIPA | 23 | Huawei, China Mobile | patrice.hede@huawei.com, Tao Sun (suntao@chinamobile.com) | Rel-10 | 45 | Maurice | HNB |  |
| 6016 | 1942.6.2 | **Stage 3 for Local IP Access** | 206d? | 2010-06-04 A | 2011-03-18 A | 100% | 2010-06-04 | 2011-03-18 | 206d? |  | C4; C1 | 6592h | 6592h | LIPA | 25 | China Mobile | Zhang Hao (zhanghao@chinamobile.com) | Rel-10 | 48 | Kimmo | HNB |  |
| 6017 | 1942.6.2.1 | CT4 part of Stage 3 for Local IP Access | 206d? | 2010-06-04 A | 2011-03-18 A | 100% | 2010-06-04 | 2011-03-18 | 206d? | finish no earlier than 2011-03-18 | C4 | 1648h | 1648h | LIPA | 25 | China Mobile | Zhang Hao (zhanghao@chinamobile.com) | Rel-10 | 48 | Kimmo | HNB |  |
| 6018 | 1942.6.2.2 | CT1 part of Stage 3 for Local IP Access | 206d? | 2010-06-04 A | 2011-03-18 A | 100% | 2010-06-04 | 2011-03-18 | 206d? | finish no earlier than 2011-03-18 | C1 | 1648h | 1648h | LIPA | 25 | China Mobile | Zhang Hao (zhanghao@chinamobile.com) | Rel-10 | 48 | Frederic | HNB |  |
| 6019 | 1942.7 | **Stage 2/3 for SIPTO for macro networks** | 387d? | 2009-09-24 A | 2011-03-18 A | 100% | 2009-09-24 | 2011-03-18 | 387d? |  | S2; C4; C1 | 17408h | 17408h | SIPTO | 23 | Huawei, China Mobile | patrice.hede@huawei.com, Tao Sun (suntao@chinamobile.com) | Rel-10 | 45 | Maurice | HNB | SIPTO |
| 6020 | 1942.7.1 | Stage 2 for SIPTO for macro networks | 261d? | 2009-09-24 A | 2010-09-23 A | 100% | 2009-09-24 | 2010-09-23 | 261d? | finish no earlier than 2010-09-23 | S2 | 2088h | 2088h | SIPTO | 23 | Huawei, China Mobile | patrice.hede@huawei.com, Tao Sun (suntao@chinamobile.com) | Rel-10 | 45 | Maurice | HNB |  |
| 6021 | 1942.7.2 | **Stage 3 for SIPTO for macro networks** | 206d? | 2010-06-04 A | 2011-03-18 A | 100% | 2010-06-04 | 2011-03-18 | 206d? |  | C4; C1 | 6032h | 6032h | SIPTO | 25 | Huawei | Caixia Qi (qcxmay@huawei.com) | Rel-10 | 48 | Kimmo | HNB |  |
| 6022 | 1942.7.2.1 | CT4 part of Stage 3 for SIPTO for macro networks | 206d? | 2010-06-04 A | 2011-03-18 A | 100% | 2010-06-04 | 2011-03-18 | 206d? | finish no earlier than 2011-03-18 | C4 | 1648h | 1648h | SIPTO | 25 | Huawei | Caixia Qi (qcxmay@huawei.com) | Rel-10 | 48 | Kimmo | HNB |  |
| 6023 | 1942.7.2.2 | CT1 part of Stage 3 for SIPTO for macro networks | 136d? | 2010-06-04 A | 2010-12-10 A | 100% | 2010-06-04 | 2010-12-10 | 136d? | finish no earlier than 2011-03-18 | C1 | 1088h | 1088h | SIPTO | 25 | Huawei | Caixia Qi (qcxmay@huawei.com) | Rel-10 | 48 | Frederic | HNB |  |
| 6024 | 1943 | **IP Flow Mobility and seamless WLAN offload** | 390d? | 2009-09-24 A | 2011-03-23 A | 100% | 2009-09-24 | 2011-03-23 | 390d? |  | S2; S1; S5; C1; C3 | 26808h | 26808h | IFOM | 23 | Qualcomm | Gerardo Giaretta (gerardo@qualcomm.com) | Rel-10 | 45 | Maurice | WLAN | IFOM |
| 6025 | 1943.1 | Stage 1 for IP Flow Mobility and seamless WLAN offload | 56d? | 2009-09-24 A | 2009-12-10 A | 100% | 2009-09-24 | 2009-12-10 | 56d? | finish no earlier than 2009-12-10 | S1 | 448h | 448h | IFOM | 23 | Qualcomm | David Williams (dwilliam@qualcomm.com) | Rel-10 | 45 | Alain | WLAN |  |
| 6026 | 1943.2 | Stage 2 for IP Flow Mobility and seamless WLAN offload | 261d? | 2009-09-24 A | 2010-09-23 A | 100% | 2009-09-24 | 2010-09-23 | 261d? | finish no earlier than 2010-09-23 | S2 | 2088h | 2088h | IFOM | 23 | Qualcomm | Gerardo Giaretta (gerardo@qualcomm.com) | Rel-10 | 45 | Maurice | WLAN |  |
| 6027 | 1943.3 | Charging for IP Flow Mobility and seamless WLAN offload | 260d? | 2010-03-25 A | 2011-03-23 A | 100% | 2010-03-25 | 2011-03-23 | 260d? | finish no earlier than 2011-03-23 | S5 | 2080h | 2080h | IFOM | 24 | Alcatel-Lucent | maryse.gardella@alcatel-lucent.com | Rel-10 | 47 | Mirko | WLAN |  |
| 6028 | 1943.4 | **Stage 3 for IP Flow Mobility and seamless WLAN offload** | 206d? | 2010-06-04 A | 2011-03-18 A | 100% | 2010-06-04 | 2011-03-18 | 206d? |  | C1; C3 | 6592h | 6592h | IFOM-CT | 25 | Qualcomm | Patrick Stupar (pstupar@qualcomm.com) | Rel-10 | 48 | Frederic | WLAN | IFOM-CT |
| 6029 | 1943.4.1 | CT1 part of Stage 3 for IP Flow Mobility and seamless WLAN offload | 206d? | 2010-06-04 A | 2011-03-18 A | 100% | 2010-06-04 | 2011-03-18 | 206d? | finish no earlier than 2011-03-18 | C1 | 1648h | 1648h | IFOM-CT | 25 | Qualcomm | Patrick Stupar (pstupar@qualcomm.com) | Rel-10 | 48 | Frederic | WLAN |  |
| 6030 | 1943.4.2 | CT3 part of Stage 3 for IP Flow Mobility and seamless WLAN offload | 206d? | 2010-06-04 A | 2011-03-18 A | 100% | 2010-06-04 | 2011-03-18 | 206d? | finish no earlier than 2011-03-18 | C3 | 1648h | 1648h | IFOM-CT | 25 | Qualcomm | Patrick Stupar (pstupar@qualcomm.com) | Rel-10 | 48 | Adrian | WLAN |  |
| 6031 | 1944 | **Enabling Coder Selection and Rate Adaptation for UTRAN and E-UTRAN for Load Adaptive Applications** | 827.4d? | 2009-07-15 A | 2012-09-07 A | 100% | 2009-07-15 | 2012-09-07 | 827.4d? |  | S2; S4; C4; C3; C1; IETF | 85939.2h | 85939.2h | ECSRA_LAA | 23 | Qualcomm | AC Mahendran (ac@qualcomm.com) | Rel-10 | 45 | Maurice |  | ECSRA_LAA |
| 6032 | 1944.1 | TR on Enabling Coder Selection and Rate Adaptation for UTRAN and E-UTRAN for Load Adaptive Applications | 186d? | 2010-01-07 A | 2010-09-23 A | 100% | 2010-01-07 | 2010-09-23 | 186d? | finish no earlier than 2010-09-23 | S2; S4 | 2976h | 2976h | ECSRA_LAA | 23 | Qualcomm | AC Mahendran (ac@qualcomm.com) | Rel-10 | 45 | Maurice |  |  |
| 6033 | 1944.2 | SA4 review of TR on Enabling Coder Selection and Rate Adaptation for UTRAN and E-UTRAN for Load Adaptive Applications | 320d? | 2009-09-24 A | 2010-12-15 A | 100% | 2009-09-24 | 2010-12-15 | 320d? | finish no earlier than 2010-12-15 | S4 | 2560h | 2560h | ECSRA_LAA | 23 | Qualcomm | AC Mahendran (ac@qualcomm.com) | Rel-10 | 45 | Paolo |  |  |
| 6034 | 1944.3 | Stage 2 for Enabling Coder Selection and Rate Adaptation for UTRAN and E-UTRAN for Load Adaptive Applications | 261d? | 2009-09-24 A | 2010-09-23 A | 100% | 2009-09-24 | 2010-09-23 | 261d? | finish no earlier than 2010-09-23 | S2 | 2088h | 2088h | ECSRA_LAA | 23 | Qualcomm | AC Mahendran (ac@qualcomm.com) | Rel-10 | 45 | Maurice |  |  |
| 6035 | 1944.4 | SA4 aspects of Enabling Coder Selection and Rate Adaptation for UTRAN and E-UTRAN for Load Adaptive Applications | 130d? | 2010-09-23 A | 2011-03-23 A | 100% | 2010-09-23 | 2011-03-23 | 130d? | finish no earlier than 2011-03-23 | S4 | 1040h | 1040h | ECSRA_LAA | 25 | Qualcomm | AC Mahendran (ac@qualcomm.com) | Rel-10 | 49 | Paolo |  |  |
| 6036 | 1944.5 | **CN aspects of Enabling Coder Selection and Rate Adaptation for UTRAN and E-UTRAN for Load Adaptive Applications** | 827.4d? | 2009-07-15 A | 2012-09-07 A | 100% | 2009-07-15 | 2012-09-07 | 827.4d? |  | C4; C3; C1 | 37560h | 37560h | ECSRA_LAA-CN | 25 | Ericsson | philip.hodges@ericsson.com | Rel-10 | 49 | Kimmo |  | ECSRA_LAA-CN |
| 6037 | 1944.5.1 | CT4 part of CN aspects of Enabling Coder Selection and Rate Adaptation for UTRAN and E-UTRAN for Load Adaptive Applications | 186d? | 2010-09-17 A | 2011-06-03 A | 100% | 2010-09-17 | 2011-06-03 | 186d? | start no earlier than 2010-09-17 | C4 | 1488h | 1488h | ECSRA_LAA-CN | 25 | Ericsson | philip.hodges@ericsson.com | Rel-10 | 49 | Kimmo |  |  |
| 6038 | 1944.5.2 | (IETF) CT3, CT4 part of CN aspects of Enabling Coder Selection and Rate Adaptation for UTRAN and E-UTRAN for Load Adaptive Applications | 827.4d? | 2009-07-15 A | 2012-09-07 A | 100% | 2009-07-15 | 2012-09-07 | 827.4d? | finish no earlier than 2012-09-07 | C3-IETF; C4-IETF | 13238.4h | 13238.4h | ECSRA_LAA-CN | 27 | Lionel Morand |  | Rel-10 | 53 | Adrian |  |  |
| 6039 | 1944.5.3 | CT3 part of CN aspects of Enabling Coder Selection and Rate Adaptation for UTRAN and E-UTRAN for Load Adaptive Applications | 186d? | 2010-09-17 A | 2011-06-03 A | 100% | 2010-09-17 | 2011-06-03 | 186d? | finish no earlier than 2011-06-03 | C3 | 1488h | 1488h | ECSRA_LAA-CN | 25 | Ericsson | philip.hodges@ericsson.com | Rel-10 | 49 | Adrian |  |  |
| 6040 | 1944.5.4 | CT1 part of CN aspects of Enabling Coder Selection and Rate Adaptation for UTRAN and E-UTRAN for Load Adaptive Applications | 186d? | 2010-09-17 A | 2011-06-03 A | 100% | 2010-09-17 | 2011-06-03 | 186d? | start no earlier than 2010-09-17 | C1 | 1488h | 1488h | ECSRA_LAA-CN | 25 | Ericsson | philip.hodges@ericsson.com | Rel-10 | 49 | Frederic |  |  |

Notes:
- 6014: -
- 6015: SP#49 completed (has impacts to RAN) / Impacted TSs and TRs: 23.060; 23.401
- 6016: CP#51 completed
- 6017: CP#51 completed / Impacted TSs and TRs: 23.008; 23.015; 29.002; 29.060; 29.272; 29.274; 29.281; 29.303
- 6018: CP#51 completed / Impacted TSs and TRs: 24.008; 24.301
- 6019: -
- 6020: SP#49 completed (SIPTO GW selection for wild card APN and for GERAN. Serving-GW selection for SIPTO. Corrections and Clarifications of the SIPTO procedure) / Impacted TSs and TRs: 23.060; 23.401
- 6021: CP#51 completed. Updated WID CP-100419=>CP-110091
- 6022: CP#51 completed. Updated WID CP-100419=>CP-110091 / Impacted TSs and TRs: 23.003; 23.008; 29.002; 29.272; 29.303
- 6023: CP#50 completed / Impacted TSs and TRs: 24.008; 24.301
- 6024: SP#51 completed. Triggered by Rel-10 TR 23.861 (UID_410043 Study on Multi Access PDN connectivity and IP flow mobility - MAPIM)
- 6025: SP#46 completed / Impacted TSs and TRs: 22.278
- 6026: SP#49 completed / Impacted TSs and TRs: 23.203; 23.402; new 23.261
- 6027: SP#51 completed / Impacted TSs and TRs: 32.240; 32.251; 32.252; 32.298; 32.299
- 6028: CP#51 completed / Impacted TSs and TRs: Stage 3
- 6029: CP#51 completed / Impacted TSs and TRs: 24.008; 24.301; 24.302; 24.303; 24.312; 24.327
- 6030: CP#51 completed / Impacted TSs and TRs: 29.212; 29.213; 29.214; 29.215
- 6031: CP#52 completed. Triggered by Rel-9 UID_440013 Vocoder rate adaptation for LTE / Impacted TSs and TRs: UTRA; LTE
- 6032: SP#48 completed / Impacted TSs and TRs: new 23.860
- 6033: SP#50 completed / Impacted TSs and TRs: new 23.860
- 6034: SP#49 completed / Impacted TSs and TRs: 23.060; 23.203; 23.228; 23.401
- 6035: SP#51 completed / Impacted TSs and TRs: 26.114
- 6036: CP#52 completed / Impacted TSs and TRs: Stage 2/3
- 6037: CP#52 completed / Impacted TSs and TRs: 23.334; 29.334; 29.238; 23.333; 29.333; 29.232; 29.332
- 6038: CP#57 completed / Impacted TSs and TRs: RFC 6679 (was draft-ietf-avtcore-ecn-for-rtp)
- 6039: CP#52 completed / Impacted TSs and TRs: 29.162; 29.163; 29.213; 29.235; 29.292
- 6040: CP#52 completed / Impacted TSs and TRs: 24.229

| ID | WBS | Task | Type | Duration | Start | Finish | Complete | Baseline start | Baseline finish | Baseline duration | Constraint | Resources | Work | Actual work | Acronym | PCG approved | Impacted TSs and TRs | WI rapporteur name | WI rapporteur e-mail | Release | TSG approved | MCC resp | Special Focus Doc | Acronym_3GU_Export | PCG stopped | TSG stopped |
| --- | --- | --- | --- | --- | --- | --- | --- | --- | --- | --- | --- | --- | --- | --- | --- | --- | --- | --- | --- | --- | --- | --- | --- | --- | --- | --- |
| 6041 | 1945 | **Extended H(e)NB features** |  | 467d? | 2008-12-11 A | 2010-09-23 A | 100% | 2008-12-11 | 2010-09-23 | 467d? |  | S1; S2; S3 | 15552h | 15552h | EHNBF | 23 | UTRA; LTE | NEC | joerg.swetina@neclab.eu | Rel-10 | 45 | Alain | HNB | EHNBF |  |  |
| 6042 | 1945.1 | Stage 1 of Extended H(e)NB features |  | 131d? | 2009-09-24 A | 2010-03-25 A | 100% | 2009-09-24 | 2010-03-25 | 131d? | finish no earlier than 2010-03-25 | S1 | 1048h | 1048h | EHNBF | 23 | 22.220 | NEC | joerg.swetina@neclab.eu | Rel-10 | 45 | Alain | HNB |  |  |  |
| 6043 | 1945.2 | IMS aspects of Architecture for Home NodeB |  | 336d? | 2008-12-11 A | 2010-03-25 A | 100% | 2008-12-11 | 2010-03-25 | 336d? | finish no earlier than 2010-03-25 | S2 | 2688h | 2688h | EHNB-IMS | 22 | New 23.832 | Alcatel-Lucent | Nicolas Drevon | Rel-10 | 42 | Maurice | HNB | EHNB-IMS |  |  |
| 6044 | 1945.3 | Extended H(e)NB Security features (Stage 2) |  | 76d? | 2010-06-10 A | 2010-09-23 A | 100% | 2010-06-10 | 2010-09-23 | 76d? | finish no earlier than 2010-09-23 | S3 | 608h | 608h | EHNBF-Sec | 25 | 33.320 | Huawei | Marcus Wong (mwong@huawei.com) | Rel-10 | 48 | Mirko | HNB | EHNBF-Sec |  |  |
| 6045 | 1946 | **Optimal Media Routing** |  | 314d? | 2010-03-25 A | 2011-06-08 A | 100% | 2010-03-25 | 2011-06-08 | 314d? |  | S2; S5; C3; C1 | 22696h | 22696h | OMR | 24 |  | Alcatel-Lucent | andy.bennett@alcatel-lucent.com | Rel-10 | 46 | Maurice |  | OMR |  |  |
| 6046 | 1946.1 | Stage 2 for Optimal Media Routing | milestone | 0d? | 2010-03-25 A | 2010-03-25 A | 100% | 2010-03-25 | 2010-03-25 | 0d? |  | S2 |  |  | OMR | 24 | 23.228 | Alcatel-Lucent | andy.bennett@alcatel-lucent.com | Rel-10 | 46 | Maurice |  |  |  |  |
| 6047 | 1946.2 | **Stage 3 for Optimal Media Routing** |  | 261d? | 2010-06-04 A | 2011-06-03 A | 100% | 2010-06-04 | 2011-06-03 | 261d? |  | C3; C1; C4 | 11648h | 11648h | OMR | 25 |  | Alcatel-Lucent | jim.calme@alcatel-lucent.com | Rel-10 | 48 | Adrian |  |  |  |  |
| 6048 | 1946.2.1 | CT3 part of Stage 3 for Optimal Media Routeing |  | 261d? | 2010-06-04 A | 2011-06-03 A | 100% | 2010-06-04 | 2011-06-03 | 261d? | finish no earlier than 2011-06-03 | C3 | 2088h | 2088h | OMR | 25 | 29.162; 29.163; 29.165; 29.235; new 29.079 | Alcatel-Lucent | jim.calme@alcatel-lucent.com | Rel-10 | 48 | Adrian |  |  |  |  |
| 6049 | 1946.2.2 | CT1 part of Stage 3 for Optimal Media Routeing |  | 206d? | 2010-06-04 A | 2011-03-18 A | 100% | 2010-06-04 | 2011-03-18 | 206d? | finish no earlier than 2011-03-18 | C1 | 1648h | 1648h | OMR | 25 | 24.229 | Alcatel-Lucent | jim.calme@alcatel-lucent.com | Rel-10 | 48 | Frederic |  |  |  |  |
| 6050 | 1946.2.3 | Deleted - CT4 part of Stage 3 for Optimal Media Routeing |  | 206d? | 2010-06-04 A | 2011-03-18 A | 100% | 2010-06-04 | 2011-03-18 | 206d? | finish no earlier than 2011-03-18 | C4 | 1648h | 1648h | OMR | 25 |  | Alcatel-Lucent | jim.calme@alcatel-lucent.com | Rel-10 | 48 | Kimmo |  |  | PCG-26 | CP-51 |
| 6051 | 1946.3 | Charging for Optimal Media Routing |  | 125d? | 2010-12-16 A | 2011-06-08 A | 100% | 2010-12-16 | 2011-06-08 | 125d? | finish no earlier than 2011-06-08 | S5 | 1000h | 1000h | OMR | 26 | 32.260; 32.298; 32.299 | Alcatel-Lucent | maryse.gardella@alcatel-lucent.com | Rel-10 | 50 | Mirko |  |  |  |  |
| 6052 | 1947 | **IMS Emergency Session Enhancements** |  | 312d? | 2010-03-25 A | 2011-06-03 A | 100% | 2010-03-25 | 2011-06-03 | 312d? |  | S1; S2; C1 | 9552h | 9552h | IESE | 24 |  | Deutsche Telekom, T-Mobile | michele.zarri@t-mobile.co.uk | Rel-10 | 47 | Maurice | Public Safety (I-A) | IESE |  |  |
| 6053 | 1947.1 | Stage 1 for IMS Emergency Session Enhancements |  | 1d? | 2010-03-25 A | 2010-03-25 A | 100% | 2010-03-25 | 2010-03-25 | 1d? | start no earlier than 2010-03-25 | S1 | 8h | 8h | IESE | 24 | 22.101 CR#0343 | Deutsche Telekom, T-Mobile | Kurt Bischinger | Rel-10 | 47 | Alain | Public Safety (I-A) |  |  |  |
| 6054 | 1947.2 | Stage 2 for IMS Emergency Session Enhancements |  | 131d? | 2010-03-25 A | 2010-09-23 A | 100% | 2010-03-25 | 2010-09-23 | 131d? | finish no earlier than 2010-09-23 | S2 | 1048h | 1048h | IESE | 24 | 23.167 | Deutsche Telekom, T-Mobile | michele.zarri@t-mobile.co.uk | Rel-10 | 47 | Maurice | Public Safety (I-A) |  |  |  |
| 6055 | 1947.3 | Stage 3 for IMS Emergency Session Enhancements |  | 126d? | 2010-12-10 A | 2011-06-03 A | 100% | 2010-12-10 | 2011-06-03 | 126d? | finish no earlier than 2011-06-03 | C1 | 1008h | 1008h | IESE | 26 | 24.229 | Deutsche Telekom | reinhard.lauster@t-mobile.at | Rel-10 | 50 | Frederic | Public Safety (I-A) |  |  |  |
| 6056 | 1948 | **S2b Mobility based on GTP** |  | 202d? | 2010-06-10 A | 2011-03-18 A | 100% | 2010-06-10 | 2011-03-18 | 202d? |  | S2; C4; C3; C1 | 12800h | 12800h | SMOG | 25 |  | Alcatel-Lucent | bruno.landais@alcatel-lucent.com | Rel-10 | 48 | Maurice | WLAN | SMOG |  |  |
| 6057 | 1948.1 | Stage 2 for S2b Mobility based on GTP |  | 76d? | 2010-06-10 A | 2010-09-23 A | 100% | 2010-06-10 | 2010-09-23 | 76d? | finish no earlier than 2010-09-23 | S2 | 608h | 608h | SMOG | 25 | 23.002; 23.203; 23.402 | Alcatel-Lucent | bruno.landais@alcatel-lucent.com | Rel-10 | 48 | Maurice | WLAN |  |  |  |
| 6058 | 1948.2 | **Stage 3 for S2b Mobility based on GTP** |  | 131d? | 2010-09-17 A | 2011-03-18 A | 100% | 2010-09-17 | 2011-03-18 | 131d? |  | C4; C3; C1 | 5728h | 5728h | SMOG-St3 | 25 |  | Alcatel-Lucent | bruno.landais@alcatel-lucent.com | Rel-10 | 49 | Kimmo | WLAN | SMOG-St3 |  |  |
| 6059 | 1948.2.1 | CT4 part of Stage 3 for S2b Mobility based on GTP |  | 131d? | 2010-09-17 A | 2011-03-18 A | 100% | 2010-09-17 | 2011-03-18 | 131d? | finish no earlier than 2011-03-18 | C4 | 1048h | 1048h | SMOG-St3 | 25 | 23.003; 23.007; 23.008; 29.273; 29.274; 29.281; 29.303 | Alcatel-Lucent | bruno.landais@alcatel-lucent.com | Rel-10 | 49 | Kimmo | WLAN |  |  |  |
| 6060 | 1948.2.2 | CT3 part of Stage 3 for S2b Mobility based on GTP |  | 131d? | 2010-09-17 A | 2011-03-18 A | 100% | 2010-09-17 | 2011-03-18 | 131d? | finish no earlier than 2011-03-18 | C3 | 1048h | 1048h | SMOG-St3 | 25 | 29.212; 29.213; 29.215 | Alcatel-Lucent | bruno.landais@alcatel-lucent.com | Rel-10 | 49 | Adrian | WLAN |  |  |  |
| 6061 | 1948.2.3 | CT1 part of Stage 3 for S2b Mobility based on GTP |  | 61d? | 2010-09-17 A | 2010-12-10 A | 100% | 2010-09-17 | 2010-12-10 | 61d? | finish no earlier than 2010-12-10 | C1 | 488h | 488h | SMOG-St3 | 25 | 24.302 | Alcatel-Lucent | bruno.landais@alcatel-lucent.com | Rel-10 | 49 | Frederic | WLAN |  |  |  |
| 6062 | 1949 | **Policy Enhancements for Sponsored Connectivity and Coherent Access to Policy related Databases** |  | 113.15d? | 2010-10-12 A | 2011-03-18 A | 100% | 2010-10-12 | 2011-03-18 | 113.15d? |  | S2; C3 | 2378.4h | 2378.4h | PEST | 26 |  | Qualcomm | AC Mahendran (ac@qualcomm.com) | Rel-10 | 50 | Maurice |  | PEST |  |  |
| 6063 | 1949.1 | Stage 2 for Policy Enhancements for Sponsored Connectivity and Coherent Access to Policy related Databases | milestone | 0d? | 2010-10-12 A | 2010-10-12 A | 100% | 2010-10-12 | 2010-12-15 | 0d? | finish no earlier than 2010-12-15 | S2 |  |  | PEST | 26 | 23.002; 23.203 | Qualcomm | AC Mahendran (ac@qualcomm.com) | Rel-10 | 50 | Maurice |  |  |  |  |
| 6064 | 1949.2 | CT3 aspects of Policy Enhancements for Sponsored Connectivity and Coherent Access to Policy related Databases |  | 71d? | 2010-12-10 A | 2011-03-18 A | 100% | 2010-12-10 | 2011-03-18 | 71d? | finish no earlier than 2011-03-18 | C3 | 568h | 568h | PEST-CT3 | 26 | 29.212; 29.213; 29.214; 29.215 | ZTE | zhou.xiaoyun@zte.com.cn | Rel-10 | 50 | Adrian |  | PEST-CT3 |  |  |

Notes:
- 6041: SP#49 completed. Adds extensions to Rel-9 functionality in UID_400035 Enhanced Home NodeB / eNodeB (EHNB)
- 6042: SP#47 completed
- 6043: SP#47 completed. Chosen solution has no normative impacts
- 6044: SP#49 completed
- 6045: CP#52 completed. SP#47 Stage 2 completed. Triggered by TR 23.894 (UID_370050 Study on System enhancements for the use of IMS servicES in CP-150local breakout)
- 6046: SP#47 completed
- 6047: CP#51 completion 03/11=>06/11. WID updated CP-100327=>CP-110134
- 6048: CP#52 completed
- 6049: CP#51 completed. WID updated CP-100327=>CP-110134
- 6050: CP#51 stopped (CT4 specs not impacted). WID updated CP-100327=>CP-110134
- 6051: SP#52 completed. Stage 3: Linked to CT3 TS 29.079 OMR within the IMS¦Stage 3 (UID_480110)
- 6052: CP#52 completed. SP#49 completed. Source of external requirements: ETSI TISPAN TS 181.019 (Business Communication Requirements)
- 6053: SP#47 completed
- 6054: SP#49 completed
- 6055: CP#52 completed
- 6056: CP#51 completed. SP#49 Stage 2 completed. Related to Rel-10 UID_470049 Study on S2b mobility based on GTP (TR23.834), UID_350027 SAE for support for non-3GPP accesses. Stage1 in Rel-8 UID_320022 Reqs for evolution of 3GPP system architecture (AIPN-SAE)
- 6057: SP#49 completed
- 6058: CP#51 Stage 3 completed
- 6059: CP#51 completed
- 6060: CP#51 completed
- 6061: CP#50 completed
- 6062: CP#51 completed. SP#50 Stage 2 completed. Triggered by the SA1,SA2 Rel-10 TR 23.813 Study on Policy solutions and enhancements (FS_PP) UID_440047. Provides Video Call seamless service continuity for 3G/LTE terminal user
- 6063: SP#51 updated WID SP-100702=>SP-110196. SP#49 work completed as SA2 CRs approved under TEI10 (SP-10557)
- 6064: CP#51 completed

| ID | WBS | Task | Duration | Start | Finish | Complete | Baseline start | Baseline finish | Baseline duration | Constraint | Resources | Work | Actual work | Acronym | PCG approved | WI rapporteur name | WI rapporteur e-mail | Release | TSG approved | MCC resp | Acronym_3GU_Export | PCG stopped | TSG stopped |
| --- | --- | --- | --- | --- | --- | --- | --- | --- | --- | --- | --- | --- | --- | --- | --- | --- | --- | --- | --- | --- | --- | --- | --- |
| 6065 | 1950 | **Lawful Interception in the 3GPP Rel-10** | 315d? | 2010-03-25 A | 2011-06-08 A | 100% | 2010-03-25 | 2011-06-08 | 315d? |  | S3 | 20480h | 20480h | LI10 | 24 | PIDS, BT | Koen Jaspers (k.b.jaspers@minjus.nl), alex.leadbeater@bt.com | Rel-10 | 47 | Mirko | LI10 |  |  |
| 6066 | 1950.1 | LI for CAT (Customer Alerting Tones) | 315d? | 2010-03-25 A | 2011-06-08 A | 100% | 2010-03-25 | 2011-06-08 | 315d? | finish no earlier than 2011-03-23 | S3 | 2520h | 2520h | LI10 | 24 | PIDS, BT | Koen Jaspers (k.b.jaspers@minjus.nl), alex.leadbeater@bt.com | Rel-10 | 47 | Mirko |  |  |  |
| 6067 | 1950.2 | LI for CRS (Customized Ringing Signal) | 315d? | 2010-03-25 A | 2011-06-08 A | 100% | 2010-03-25 | 2011-06-08 | 315d? | finish no earlier than 2011-03-23 | S3 | 2520h | 2520h | LI10 | 24 | PIDS, BT | Koen Jaspers (k.b.jaspers@minjus.nl), alex.leadbeater@bt.com | Rel-10 | 47 | Mirko |  |  |  |
| 6068 | 1950.3 | LI for EPS enhancements | 315d? | 2010-03-25 A | 2011-06-08 A | 100% | 2010-03-25 | 2011-06-08 | 315d? | finish no earlier than 2011-03-23 | S3 | 2520h | 2520h | LI10 | 24 | PIDS, BT | Koen Jaspers (k.b.jaspers@minjus.nl), alex.leadbeater@bt.com | Rel-10 | 47 | Mirko |  |  |  |
| 6069 | 1950.4 | LI for VCC (Voice Call Continuity) | 260d? | 2010-03-25 A | 2011-03-23 A | 100% | 2010-03-25 | 2011-03-23 | 260d? | finish no earlier than 2011-03-23 | S3 | 2080h | 2080h | LI10 | 24 | PIDS, BT | Koen Jaspers (k.b.jaspers@minjus.nl), alex.leadbeater@bt.com | Rel-10 | 47 | Mirko |  |  |  |
| 6070 | 1950.5 | LI for MEDIASEC (IMS Media security) | 260d? | 2010-03-25 A | 2011-03-23 A | 100% | 2010-03-25 | 2011-03-23 | 260d? | finish no earlier than 2011-03-23 | S3 | 2080h | 2080h | LI10 | 24 | PIDS, BT | Koen Jaspers (k.b.jaspers@minjus.nl), alex.leadbeater@bt.com | Rel-10 | 47 | Mirko |  |  |  |
| 6071 | 1950.6 | LI for H(e)NB also with Local IP Access and Selected IP Traffic Offload (LIPA, SIPTO) | 260d? | 2010-03-25 A | 2011-03-23 A | 100% | 2010-03-25 | 2011-03-23 | 260d? | finish no earlier than 2011-03-23 | S3 | 2080h | 2080h | LI10 | 24 | PIDS, BT | Koen Jaspers (k.b.jaspers@minjus.nl), alex.leadbeater@bt.com | Rel-10 | 47 | Mirko |  |  |  |
| 6072 | 1950.7 | LI for MBMS enhancements | 260d? | 2010-03-25 A | 2011-03-23 A | 100% | 2010-03-25 | 2011-03-23 | 260d? | finish no earlier than 2011-03-23 | S3 | 2080h | 2080h | LI10 | 24 | PIDS, BT | Koen Jaspers (k.b.jaspers@minjus.nl), alex.leadbeater@bt.com | Rel-10 | 47 | Mirko |  |  |  |
| 6073 | 1950.8 | LI for LCLS (Local Call Local Switch) | 260d? | 2010-03-25 A | 2011-03-23 A | 100% | 2010-03-25 | 2011-03-23 | 260d? | finish no earlier than 2011-03-23 | S3 | 2080h | 2080h | LI10 | 24 | PIDS, BT | Koen Jaspers (k.b.jaspers@minjus.nl), alex.leadbeater@bt.com | Rel-10 | 47 | Mirko |  |  |  |
| 6074 | 1951 | Optimization of IMS based PSS and MBMS User Service | 260d? | 2010-03-25 A | 2011-03-23 A | 100% | 2010-03-25 | 2011-03-23 | 260d? | finish no earlier than 2011-03-23 | S4 | 2080h | 2080h | OPT_IMS_PSS_MBMS_US | 24 | Ericsson | markus.kampmann@ericsson.com | Rel-10 | 47 | Paolo | OPT_IMS_PSS_MBMS_US |  |  |
| 6075 | 1952 | **HTTP-based Streaming and Download Services** | 392d? | 2010-03-25 A | 2011-09-21 A | 100% | 2010-03-25 | 2011-09-21 | 392d? |  | S4; IETF | 10468.8h | 10468.8h | HTTP_SDS | 24 | Qualcomm | Thomas Stockhammer (c_tstock@qualcomm.com) | Rel-10 | 47 | Paolo | HTTP_SDS |  |  |
| 6076 | 1952.1 | HTTP-based Streaming and Download Services in 3GPP | 315d? | 2010-03-25 A | 2011-06-08 A | 100% | 2010-03-25 | 2011-06-08 | 315d? | finish no earlier than 2011-05-26 | S4 | 2520h | 2520h | HTTP_SDS | 24 | Qualcomm | Thomas Stockhammer (c_tstock@qualcomm.com) | Rel-10 | 47 | Paolo |  |  |  |
| 6077 | 1952.2 | (IETF) HTTP-based Streaming and Download Services in 3GPP | 211.6d? | 2010-03-25 A | 2011-09-21 A | 100% | 2010-03-25 | 2011-09-21 | 211.6d? | start no earlier than 2010-03-25 | S4-IETF | 1676.8h | 1676.8h | HTTP_SDS | 27 |  |  | Rel-10 | 52 | Paolo |  |  |  |
| 6078 | 1953 | PSS and MBMS enhancements | 205d? | 2010-06-10 A | 2011-03-23 A | 100% | 2010-06-10 | 2011-03-23 | 205d? | finish no earlier than 2011-03-23 | S4 | 1640h | 1640h | MBS_Enh | 25 | Ericsson | Markus.Kampmann@ericsson.com | Rel-10 | 48 | Paolo | MBS_Enh |  |  |
| 6079 | 1954 | Enhancements and Addition of Audio Tests to 26.131 and 26.132 | 260d? | 2010-06-10 A | 2011-06-08 A | 100% | 2010-06-10 | 2011-06-08 | 260d? | finish no earlier than 2011-06-08 | S4 | 2080h | 2080h | EAAT | 25 | Vodafone | ramin.afchar@vodafone.com | Rel-10 | 48 | Paolo | EAAT |  |  |
| 6080 | 1955 | Video Coding Enhancements in MTSI | 3d? | 2011-03-21 A | 2011-03-23 A | 100% | 2011-03-21 | 2011-03-23 | 3d? | start no earlier than 2011-03-21 | S4 | 24h | 24h | VCEM | 26 | Ericsson | frederic.gabin@ericsson.com | Rel-10 | 51 | Paolo | VCEM |  |  |
| 6081 | 1956 | **Rel-10 Operations, Administration, Maintenance and Provisioning (OAM&P)** | 467d? | 2009-12-10 A | 2011-09-21 A | 100% | 2009-12-10 | 2011-09-21 | 467d? |  | S5; C4 | 54144h | 54144h | OAM10 | 24 |  |  | Rel-10 | 46 | Mirko | OAM10 |  |  |
| 6082 | 1956.1 | **Rel-10 Network Infrastructure Management** | 467d? | 2009-12-10 A | 2011-09-21 A | 100% | 2009-12-10 | 2011-09-21 | 467d? |  | S5 | 14592h | 14592h | OAM10-NIM | 24 |  |  | Rel-10 | 46 | Mirko | OAM10-NIM |  |  |
| 6083 | 1956.1.1 | Common RAT Network Resource Model (NRM) | 390d? | 2009-12-10 A | 2011-06-08 A | 100% | 2009-12-10 | 2011-06-08 | 390d? | finish no earlier than 2011-06-08 | S5 | 3120h | 3120h | RAT_NRM_common | 24 | Ericsson | robert.petersen@ericsson.com | Rel-10 | 46 | Mirko | RAT_NRM_common |  |  |
| 6084 | 1956.1.2 | IRP Solution Set specification organisation improvements | 260d? | 2010-03-25 A | 2011-03-23 A | 100% | 2010-03-25 | 2011-03-23 | 260d? | finish no earlier than 2011-03-23 | S5 | 2080h | 2080h | OAM-IRP-SS | 24 | Nokia Siemens Networks, Huawei | Jörg Schmidt (J.Schmidt@nsn.com), Lan Zou (zlan@huawei.com) | Rel-10 | 47 | Mirko | OAM-IRP-SS |  |  |
| 6085 | 1956.1.3 | Deleted - Service Oriented Architecture (SOA) for IRP continuation from Rel-9 | 260d? | 2010-03-25 A | 2011-03-23 A | 100% | 2010-03-25 | 2011-03-23 | 260d? | finish no earlier than 2011-06-08 | S5 | 2080h | 2080h | OAM-SOA-IRP | 24 | Nokia Siemens Networks, Ericsson | Jörg Schmidt (J.Schmidt@NSN.com), edwin.tse@ericsson.com | Rel-10 | 47 | Mirko | OAM-SOA-IRP | PCG-26 | SP-51 |
| 6086 | 1956.1.4 | IRP Overview, Profiles & Usage Guide | 260d? | 2010-06-10 A | 2011-06-08 A | 100% | 2010-06-10 | 2011-06-08 | 260d? | finish no earlier than 2011-06-08 | S5 | 2080h | 2080h | OAM-NIM-IRP_OPU | 25 | Nokia Siemens Networks | Jörg Schmidt (J.Schmidt@NSN.com) | Rel-10 | 48 | Mirko | OAM-NIM-IRP_OPU |  |  |
| 6087 | 1956.1.5 | Alarm Correlation and Root Cause Analysis | 133d? | 2011-03-23 A | 2011-09-21 A | 100% | 2011-03-23 | 2011-09-21 | 133d? | finish no earlier than 2011-09-21 | S5 | 1048h | 1048h | OAM-AC-RCA | 26 | Ericsson | brendan.hassett@ericsson.com | Rel-10 | 51 | Mirko | OAM-AC-RCA |  |  |
| 6088 | 1956.1.6 | Inventory Management Network Resource Model enhancements | 56d? | 2011-03-23 A | 2011-06-08 A | 100% | 2011-03-23 | 2011-06-08 | 56d? | start no earlier than 2011-03-23 | S5 | 448h | 448h | OAM-IM-NMR | 26 | Nokia Siemens Networks | olaf.pollakowski@nsn.com | Rel-10 | 51 | Mirko | OAM-IM-NMR |  |  |

Notes:
- 6065: SP#52 completed / Impacted TSs and TRs: 33.106 (LI requirements); 33.107 (LI architecture and functions); 33.108 (Handover interface for LI)
- 6066: SP#52 completed / Impacted TSs and TRs: 33.106; 33.107; 33.108
- 6067: SP#52 completed / Impacted TSs and TRs: 33.106; 33.107; 33.108
- 6068: SP#52 completed / Impacted TSs and TRs: 33.106; 33.107; 33.108
- 6069: SP#51 completed / Impacted TSs and TRs: 33.106; 33.107; 33.108
- 6070: SP#51 completed / Impacted TSs and TRs: 33.106; 33.107; 33.108
- 6071: SP#51 completed / Impacted TSs and TRs: 33.106; 33.107; 33.108
- 6072: SP#51 completed / Impacted TSs and TRs: 33.106; 33.107; 33.108
- 6073: SP#51 completed / Impacted TSs and TRs: 33.106; 33.107; 33.108
- 6074: SP#51 completed. Work to enhance UID_430046 Rel-9 IMS_PSS_MBMS_US_EXT / Impacted TSs and TRs: 26.237
- 6075: SP#52 completed. Work to enhance UID_430038 Rel-9 PSS and MBMS extensions
- 6076: SP#52 completed / Impacted TSs and TRs: 26.234; 26.244; 26.346; new 26.247
- 6077: SP#53/IETF#81: Draft not included in 3GPP documentation. Dec.14: IETF RFC added / Impacted TSs and TRs: RFC 6381 (was draft-gellens-mime-bucket-bis)
- 6078: SP#51 completed. Linked to Rel-9 Feature UID_430038 PSS and MBMS extensions (PMA-MBS_Ext). / Impacted TSs and TRs: 26.234; 26.346
- 6079: SP#52 completed. Reduce fragmentation in acoustic testing (3GPP SA4, ETSI STQ, GCF CAG, CTIA) & Review existing acoustic tests to determine need for new spec / Impacted TSs and TRs: 26.131; 26.132
- 6080: SP#51 completed. Linked to Rel-7 UID_7040 Multimedia Telephony Service for IMS - Media handling and interaction in MTSI (MTSI-MHI) / Impacted TSs and TRs: 26.114
- 6081: OAM10 is an umbrella Feature also for OAM&P related TEI10 type of changes that are not part of any other dedicated feature/WI / Impacted TSs and TRs: 30.820
- 6082: umbrella BB
- 6083: SP#52 completed. Share equipment btw several RATs (RET,TMA,repeaters) to reduce costs. With existing modelling is difficult to see that several cells are affected when an antenna tilt is changed etc / Impacted TSs and TRs: 32.616; 32.642; 32.646; 32.652; 32.656; 32.762; 32.766 new (32.791; 32.792; 32.796)
- 6084: SP#51 completed / Impacted TSs and TRs: 32.153; new (32.111-6.32.126.32.176.32.306.32.316.32.326.32.336.32.346.32.356.32.366.32.376.32.386.32.396.32.416.32.446.32.506/26/36.32.606.32.616.32.626.32.636.32.646.32.656.32.666.32.676.32.696.32.716.32.726.32.736.32.746.32.756.32.766.32.776.32.786)
- 6085: SP#51 work stopped (Reason: lack of progress). Continuation of Rel-9 UID_440065 SOA for IRP (covering SOA Architecture & SOA-supporting Solution Set) to address SOA conforming Registration & Discovery capabilities / Impacted TSs and TRs: 32.101; 32.150
- 6086: SP#52 completed. Updated WID SP-100777=>SP-110277 / Impacted TSs and TRs: new 32.103
- 6087: SP#53 completed. Triggered by Rel-10 TR 32.832 Study on Alarm Correlation and Alarm Root Cause Analysis UID_480045 & TR 32.829 Study on Harmonization of 3GPP Alarm IRP and TMF Interface Program Fault Management UID_460038 / Impacted TSs and TRs: 32.111-1; 32.111-2; 32.111-6
- 6088: SP#52 completed. Inventory NRM specified in Rel-6 is mainly hardware related. Rel-10 TR 32.828 recommends extending the scope of inventory NRM. Additionally, NGMN Top OPE Recs, v1.0 sets inventory enhancements as one of top 10 priority items / Impacted TSs and TRs: 32.690; 32.691; 32.692; 32.696

| ID | WBS | Task | Duration | Start | Finish | Complete | Baseline start | Baseline finish | Baseline duration | Constraint | Resources | Work | Actual work | Acronym | PCG approved | Release | TSG approved | MCC resp | Special Focus Doc | Acronym_3GU_Export | WI rapporteur name |
| --- | --- | --- | --- | --- | --- | --- | --- | --- | --- | --- | --- | --- | --- | --- | --- | --- | --- | --- | --- | --- | --- |
| 6089 | 1956.2 | **Rel-10 Self-Organizing Networks (SON) - OAM aspects** | 390d? | 2009-12-10 A | 2011-06-08 A | 100% | 2009-12-10 | 2011-06-08 | 390d? |  | S5 | 11000h | 11000h | OAM10-SON | 24 | Rel-10 | 46 | Mirko | SON | OAM10-SON |  |
| 6090 | 1956.2.1 | SON Self-optimization management continuation | 390d? | 2009-12-10 A | 2011-06-08 A | 100% | 2009-12-10 | 2011-06-08 | 390d? | finish no earlier than 2011-03-23 | S5 | 3120h | 3120h | LTE-SON-OAM_SO | 24 | Rel-10 | 46 | Mirko | SON | LTE-SON-OAM_SO | Huawei |
| 6091 | 1956.2.2 | SON Self-healing management | 335d? | 2009-12-10 A | 2011-03-23 A | 100% | 2009-12-10 | 2011-03-23 | 335d? | finish no earlier than 2011-03-23 | S5 | 2680h | 2680h | LTE-SON-OAM_SH | 24 | Rel-10 | 46 | Mirko | SON | LTE-SON-OAM_SH | ZTE |
| 6092 | 1956.2.3 | OAM aspects of Energy Saving in Radio Networks | 260d? | 2010-03-25 A | 2011-03-23 A | 100% | 2010-03-25 | 2011-03-23 | 260d? | finish no earlier than 2011-03-23 | S5 | 2080h | 2080h | OAM-ES | 24 | Rel-10 | 47 | Mirko | SON | OAM-ES | Nokia Siemens Networks |
| 6093 | 1956.3 | Rel-10 Subscription Management (SuM) evolution | 260d? | 2010-03-25 A | 2011-03-23 A | 100% | 2010-03-25 | 2011-03-23 | 260d? | finish no earlier than 2011-03-23 | S5 | 2080h | 2080h | OAM10-SuM | 24 | Rel-10 | 47 | Mirko |  | OAM10-SuM | Ericsson |
| 6094 | 1956.4 | **Rel-10 Performance Management** | 315d? | 2010-03-25 A | 2011-06-08 A | 100% | 2010-03-25 | 2011-06-08 | 315d? |  | S5; C4 | 19000h | 19000h |  | 24 | Rel-10 | 47 | Mirko |  |  |  |
| 6095 | 1956.4.1 | Key Performance Indicators (KPIs) for IMS | 260d? | 2010-03-25 A | 2011-03-23 A | 100% | 2010-03-25 | 2011-03-23 | 260d? | finish no earlier than 2011-03-23 | S5 | 2080h | 2080h | OAM-PM-KPI_IMS | 24 | Rel-10 | 47 | Mirko |  | OAM-PM-KPI_IMS | China Mobile |
| 6096 | 1956.4.2 | Key Performance Indicators (KPIs) for EPC | 260d? | 2010-03-25 A | 2011-03-23 A | 100% | 2010-03-25 | 2011-03-23 | 260d? | finish no earlier than 2011-03-23 | S5 | 2080h | 2080h | OAM-PM-KPI_EPC | 24 | Rel-10 | 47 | Mirko |  | OAM-PM-KPI_EPC | China Mobile |
| 6097 | 1956.4.3 | **Management of UE based network performance measurements** | 315d? | 2010-03-25 A | 2011-06-08 A | 100% | 2010-03-25 | 2011-06-08 | 315d? |  | S5; C4 | 7720h | 7720h | OAM-PM-UE | 24 | Rel-10 | 47 | Mirko |  | OAM-PM-UE | Huawei, Nokia Siemens Networks, Ericsson |
| 6098 | 1956.4.3.1 | SA5 aspects of Management of UE based network performance measurements | 315d? | 2010-03-25 A | 2011-06-08 A | 100% | 2010-03-25 | 2011-06-08 | 315d? | finish no earlier than 2011-06-08 | S5 | 2520h | 2520h |  | 24 | Rel-10 | 47 | Mirko |  |  | Huawei, Nokia Siemens Networks, Ericsson |
| 6099 | 1956.4.3.2 | CN aspects of Management of UE based network performance measurements | 20d? | 2011-02-21 A | 2011-03-18 A | 100% | 2011-02-21 | 2011-03-18 | 20d? | start no earlier than 2011-02-21 | C4 | 160h | 160h |  | 26 | Rel-10 | 51 | Kimmo |  |  | Nokia Siemens Networks |
| 6100 | 1956.4.4 | 3G HNB and LTE HeNB Subsystem performance measurements | 260d? | 2010-03-25 A | 2011-03-23 A | 100% | 2010-03-25 | 2011-03-23 | 260d? | finish no earlier than 2011-03-23 | S5 | 2080h | 2080h | OAM-PM-HeNS | 24 | Rel-10 | 47 | Mirko | HNB | OAM-PM-HeNS | China Mobile |
| 6101 | 1957 | **Rel-10 Charging Management small Enhancements** | 470d? | 2009-06-04 A | 2011-03-23 A | 100% | 2009-06-04 | 2011-03-23 | 470d? |  | S5 | 7520h | 7520h | CH10 | 24 | Rel-10 | 47 | Mirko | WLAN | CH10 |  |
| 6102 | 1957.1 | IWLAN mobility charging | 470d? | 2009-06-04 A | 2011-03-23 A | 100% | 2009-06-04 | 2011-03-23 | 470d? | finish no earlier than 2011-03-23 | S5 | 3760h | 3760h | eIWLAN_Mob | 23 | Rel-10 | 44 | Mirko | WLAN | eIWLAN_Mob | Orange |
| 6103 | 1958 | **Advice of Charge (AoC) service support enhancements** | 312d? | 2010-03-25 A | 2011-06-03 A | 100% | 2010-03-25 | 2011-06-03 | 312d? |  | S5; C1 | 8560h | 8560h | eAoC | 24 | Rel-10 | 47 | Mirko |  | eAoC | Deutsche Telekom |
| 6104 | 1958.1 | SA5 part - AoC enhancements | 260d? | 2010-03-25 A | 2011-03-23 A | 100% | 2010-03-25 | 2011-03-23 | 260d? | finish no earlier than 2011-03-23 | S5 | 2080h | 2080h | eAoC | 24 | Rel-10 | 47 | Mirko |  |  | Deutsche Telekom |
| 6105 | 1958.2 | CT1 part - AoC enhancements (Stage 3) | 186d? | 2010-09-17 A | 2011-06-03 A | 100% | 2010-09-17 | 2011-06-03 | 186d? | finish no earlier than 2011-06-03 | C1 | 1488h | 1488h | eAoC | 25 | Rel-10 | 49 | Frederic |  |  | Deutsche Telekom |
| 6106 | 1959 | IMS Stage 3 IETF Protocol Alignment - phase 4 | 261d? | 2010-03-19 A | 2011-03-18 A | 100% | 2010-03-19 | 2011-03-18 | 261d? | finish no earlier than 2011-03-18 | C1 | 2088h | 2088h | IMSProtoc4 | 24 | Rel-10 | 47 | Frederic |  | IMSProtoc4 | Alcatel-Lucent |
| 6107 | 1960 | Enhanced User Data Convergence (UDC) Model | 206d? | 2010-06-04 A | 2011-03-18 A | 100% | 2010-06-04 | 2011-03-18 | 206d? | finish no earlier than 2011-03-18 | C4 | 1648h | 1648h | eUDC | 25 | Rel-10 | 48 | Kimmo |  | eUDC | China Mobile |
| 6108 | 1961 | **Further improvements of II-NNI Stage 3 based on operational feedback and evolution of other specifications** | 724d? | 2010-06-04 A | 2013-03-01 A | 100% | 2010-06-04 | 2013-03-01 | 724d? |  | C3 | 10625.9h | 10625.9h | II-NNI2 | 25 | Rel-10 | 48 | Adrian |  | II-NNI2 | Orange |
| 6109 | 1961.1 | Further improvements of II-NNI Stage 3 | 206d? | 2010-06-04 A | 2011-03-18 A | 100% | 2010-06-04 | 2011-03-18 | 206d? | start no earlier than 2010-06-04 | C3 | 1648h | 1648h | II-NNI2 | 25 | Rel-10 | 48 | Adrian |  |  | Orange |
| 6110 | 1961.2 | (IETF) Further improvements of II-NNI Stage 3 (RFC 6794) | 230d? | 2012-04-20 A | 2013-03-01 A | 100% | 2012-04-20 | 2013-03-01 | 230d? | finish no earlier than 2013-03-01 | C3-IETF | 1832h | 1832h | II-NNI2 | 29 | Rel-10 | 56 | Adrian |  |  | Lionel Morand |
| 6111 | 1961.3 | (IETF) Further improvements of II-NNI Stage 3 (RFC 6809) | 170d? | 2012-04-20 A | 2012-12-07 A | 100% | 2012-04-20 | 2012-12-07 | 170d? | finish no earlier than 2012-12-04 | C3-IETF | 1353.89h | 1353.89h | II-NNI2 | 29 | Rel-10 | 56 | Adrian |  |  | christer.holmberg@ericsson.com |
| 6112 | 1962 | AT Commands for IMS-configuration | 206d? | 2010-06-04 A | 2011-03-18 A | 100% | 2010-06-04 | 2011-03-18 | 206d? |  | C1 | 1648h | 1648h | AT_IMS | 25 | Rel-10 | 48 | Frederic |  | AT_IMS | Ericsson |
| 6113 | 1963 | AT Commands for USIM Application Toolkit (USAT) | 131d? | 2010-09-17 A | 2011-03-18 A | 100% | 2010-09-17 | 2011-03-18 | 131d? |  | C1 | 52.4h | 52.4h | AT_UICC | 25 | Rel-10 | 49 | Frederic |  | AT_UICC | ST-Ericsson |
| 6114 | 1964 | Communication Control for IMS by USIM (Stage 3) | 131d? | 2010-09-17 A | 2011-03-18 A | 100% | 2010-09-17 | 2011-03-18 | 131d? | start no earlier than 2010-09-17 | C6 | 1048h | 1048h | CC_IMS_USIM | 25 | Rel-10 | 49 | Xavier |  | CC_IMS_USIM | Gemalto |
| 6115 | 1965 | Dynamic view of SIP message for Inter-IMS Network to Network Interface (II-NNI) (Stage 3) | 126d? | 2010-12-10 A | 2011-06-03 A | 100% | 2010-12-10 | 2011-06-03 | 126d? | finish no earlier than 2011-06-03 | C3 | 1008h | 1008h | NNI_DV | 26 | Rel-10 | 50 | Adrian |  | NNI_DV | NTT |
| 6116 | 1966 | Introduction of Smart Card Web Server launch functionality | 71d? | 2010-12-10 A | 2011-03-18 A | 100% | 2010-12-10 | 2011-03-18 | 71d? | finish no earlier than 2011-03-18 | C6 | 568h | 568h | SCWS_L | 26 | Rel-10 | 50 | Xavier |  | SCWS_L | Telecom Italia |
| 6117 | 1967 | USAT using AT Commands | 71d? | 2010-12-10 A | 2011-03-18 A | 100% | 2010-12-10 | 2011-03-18 | 71d? | finish no earlier than 2011-03-18 | C6 | 568h | 568h | USAT_AT | 26 | Rel-10 | 50 | Xavier |  | USAT_AT | Giesecke & Devrient |

Notes:
- 6089: umbrella BB
- 6090: SP#52 completed. Cont'd Rel-9 SON self-optimization management UID_390007 / Impacted TSs and TRs: 32.425; 32.521; 32.522; 32.526; 32.762; 32.766 / WI rapporteur e-mail: Lan Zou (zlan@huawei.com)
- 6091: SP#51 completed. WID updated SP-100776=>SP-110150. Work moved to Rel-10 after split of the Rel-9 UID_390007 SON self-optimization (removed Self-Healing handling) / Impacted TSs and TRs: 32.522; 32.526; 32.762; 32.766; new 32.541 / WI rapporteur e-mail: zhu.weihong@zte.com.cn
- 6092: SP#51 completed. WID updated SP-100226=>SP-110128. Triggered by Rel-10 TR 32.826 Study on Telecommunication Management¦Energy Savings Management (FS_OAM_ESM) UID_430044 / Impacted TSs and TRs: 32.425; 32.522; 32.526; 32.626; 32.762; 32.766; new 32.551 / WI rapporteur e-mail: clemens.suerbaum@nsn.com
- 6093: SP#51 completed / Impacted TSs and TRs: 32.172; 32.175; 32.176 / WI rapporteur e-mail: leo.yang@ericsson.com
- 6094: umbrella BB
- 6095: SP#51 completed / Impacted TSs and TRs: new 32.454 / WI rapporteur e-mail: Li Jian (lijian@chinamobile.com), Liang Shuangchun (liangshuangchun@cmdi.chinamobile.com)
- 6096: SP#51 completed / Impacted TSs and TRs: new 32.455 / WI rapporteur e-mail: Li Jian (lijian@chinamobile.com), Liang Shuangchun (liangshuangchun@cmdi.chinamobile.com)
- 6097: SP#52 completed. Stage 2/3. Linked to UID_460003 Minimization of drive tests for E-UTRAN and UTRAN (MDT_UMTSLTE) / WI rapporteur e-mail: Zou Lan (zlan@huawei.com), gyula.bodog@nsn.com, ulf.hubinette@ericsson.com
- 6098: SP#52 completed / Impacted TSs and TRs: 32.421; 32.422; 32.423; 32.441; 32.442; 32.446 / WI rapporteur e-mail: Zou Lan (zlan@huawei.com), gyula.bodog@nsn.com, ulf.hubinette@ericsson.com
- 6099: CP#51 completed under the SA5 WI code / Impacted TSs and TRs: 23.008 (CR#0330); 29.002 (CR#1007); 29.230 (CR#0207); 29.272 (CR#0329) / WI rapporteur e-mail: ulrich.wiehe@nsn.com
- 6100: SP#51 completed / Impacted TSs and TRs: 32.582; 32.592; new (32.452; 32.453) / WI rapporteur e-mail: Chen Gang (chengang@chinamobile.com)
- 6101: CH10 is an umbrella Feature also for OAM&P related TEI10 type of changes that are not part of any other dedicated feature/WI / Impacted TSs and TRs: 30.820
- 6102: SP#51 completed. RAT differentiation for charging. Completes Rel-8 Feature IWLAN_Mob UID_370049 Mobility between 3GPP-WLAN Interworking and 3GPP Systems. Cooperation with CT1,CT3 on affected protocols / Impacted TSs and TRs: 32.240; 32.252; 32.298; 32.299 / WI rapporteur e-mail: Jean-Luc Garcia (jl.garcia@orange-ftgroup.com)
- 6103: CP#52 completed. SP#51 completed SA5. Continuation of Rel-8 BB UID_80042: Advice of Charge (AoC) support in IMS Charging (IMSTSS). Stage 2/3 work / WI rapporteur e-mail: matthias.seibel@telekom.de
- 6104: SP#51 completed. SA1 Stage 1 in 22.115 / Impacted TSs and TRs: 32.275; 32.280; 32.298; 32.299 / WI rapporteur e-mail: matthias.seibel@telekom.de
- 6105: CP#52 completed. SA1 Stage 1 in 22.115, 22.173, 22.024. Add mobile-specific CAI format and volume charging elements. Extensions to existing AoC XML / Impacted TSs and TRs: 24.647 / WI rapporteur e-mail: reinhard.lauster@t-mobile.at
- 6106: CP#51 completed. Ensure protocol alignment between 3GPP Stage 3 IMS work and IETF. Review capabilities provided in SIP by IETF and document whether these capabilities are supported in the IM CN Subsystem or not / Impacted TSs and TRs: 23.218; 24.229; 24.930 / WI rapporteur e-mail: keith.drage@alcatel-lucent.com
- 6107: CP#51 completed. Specify CRUD (Create/Read/Update/Delete) operations based on SOAP protocol, which may be used by the applications having no high real-time requirement to the data access operations / Impacted TSs and TRs: 29.335 / WI rapporteur e-mail: Lan Sizhong (lansizhong@chinamobile.com)
- 6108: Improvements of Rel-9 Feature UID_440027 Operational description of the Inter-IMS Network to Network Interface (II-NNI) / WI rapporteur e-mail: beata.dobrowolska@orange-ftgroup.com
- 6109: CP#51 completed / Impacted TSs and TRs: 29.165 / WI rapporteur e-mail: beata.dobrowolska@orange-ftgroup.com
- 6110: CP#59 completed AUTH 48 RFC-to-be-6794 / Impacted TSs and TRs: RFC 6794 (was draft-ietf-sip-session-policy-framework) / WI rapporteur e-mail: Lionel Morand
- 6111: CP#58 completed / Impacted TSs and TRs: RFC 6809 (was draft-ietf-sipcore-proxy-feature) / WI rapporteur e-mail: Christer Holmberg
- 6112: CP#51 completed. Specify 1) IMS-related AT-commands to configure MT and 2) IMS-related unsolicited response codes from MT to present to end-user / Impacted TSs and TRs: 27.007 / WI rapporteur e-mail: atle.monrad@ericsson.com
- 6113: CP#51 completed / Impacted TSs and TRs: 27.007 / WI rapporteur e-mail: magnus.mk.karlsson@stericsson.com
- 6114: CP#51 completed. Stage 1 in TS 22.038 USAT service description. Linked to CT6's UID_1273 Rel-5 BB Provisioning of IP-based multimedia services (24.229, 31.103) and UID_390021 Rel-8 BB CT6 aspects of SAE (31.102, 31.111) / Impacted TSs and TRs: 31.102; 31.103; 31.111 / WI rapporteur e-mail: Denis.Lheriteau@gemalto.com
- 6115: CP#52 completed. Linked to CT3 Rel-10 Feature UID_480014 Further improvements of II-NNI Stage 3 based on operational feedback and evolution of other specifications (II-NNI2) / Impacted TSs and TRs: 29.165 / WI rapporteur e-mail: arai.kenjiro@lab.ntt.co.jp
- 6116: CP#51 completed. Define a solution which allows enabling to launch Smart Card Web Server servicES in CP-150an easy and simple manner / Impacted TSs and TRs: 31.102 / WI rapporteur e-mail: davide.pratone@telecomitalia.it
- 6117: CP#51 completed. Stage 3 based on SA1 22.038CR#37r1 (Make USAT proactive capability reqs applicable to ME as a whole without regard to any particular configuration¦e.g. a modem connected to an external display) / Impacted TSs and TRs: Stage 3 31.102; 31.111 / WI rapporteur e-mail: enric.fort@gi-de.com

| ID | WBS | Task | Type | Duration | Start | Finish | Complete | Baseline start | Baseline finish | Baseline duration | Constraint | Resources | Work | Actual work | Acronym | PCG approved | WI rapporteur name | WI rapporteur e-mail | Release | TSG approved | MCC resp | Acronym_3GU_Export | Status Report | Special Focus Doc | PCG stopped | TSG stopped |
| --- | --- | --- | --- | --- | --- | --- | --- | --- | --- | --- | --- | --- | --- | --- | --- | --- | --- | --- | --- | --- | --- | --- | --- | --- | --- | --- |
| 6118 | 1968 | **Single Radio Voice Call Continuity (SRVCC) enhancements (Stage 3)** |  | 528d? | 2010-12-10 A | 2012-12-07 A | 100% | 2010-12-10 | 2012-12-07 | 528d? |  | C1; C4; IETF | 17295.4h | 17295.4h | eSRVCC | 26 | China Mobile | Jiang Y (jiangyi@chinamobile.com) | Rel-10 | 50 | Frederic | eSRVCC |  |  |  |  |
| 6119 | 1968.1 | CT1 part of Stage 3 for SRVCC enhancements |  | 71d? | 2010-12-10 A | 2011-03-18 A | 100% | 2010-12-10 | 2011-03-18 | 71d? | finish no earlier than 2011-03-18 | C1 | 568h | 568h | eSRVCC | 26 | China Mobile | Jiang Y (jiangyi@chinamobile.com) | Rel-10 | 50 | Frederic |  |  |  |  |  |
| 6120 | 1968.2 | CT4 part of Stage 3 for SRVCC enhancements |  | 71d? | 2010-12-10 A | 2011-03-18 A | 100% | 2010-12-10 | 2011-03-18 | 71d? | finish no earlier than 2011-03-18 | C4 | 568h | 568h | eSRVCC | 26 | China Mobile | Jiang Y (jiangyi@chinamobile.com) | Rel-10 | 50 | Kimmo |  |  |  |  |  |
| 6121 | 1968.3 | (IETF) CT1 part of Stage 3 for SRVCC enhancements (RFC 6809) |  | 436.8d? | 2010-12-10 A | 2012-12-07 A | 100% | 2010-12-10 | 2012-12-07 | 436.8d? | finish no earlier than 2013-03-01 | C1-IETF | 3487.38h | 3487.38h | eSRVCC | 27 | christer.holmberg@ericsson.com | christer.holmberg@ericsson.com | Rel-10 | 52 | Frederic |  |  |  |  |  |
| 6122 | 1969 | **Single Radio Voice Call Continuity (SRVCC) in alerting phase (Stage 3)** |  | 589d? | 2010-12-10 A | 2013-03-01 A | 100% | 2010-12-10 | 2013-03-01 | 589d? |  | C1; R5 | 11440h | 11440h | aSRVCC | 26 | ZTE | li.shitao@zte.com.cn | Rel-10 | 50 | Frederic | aSRVCC |  |  |  |  |
| 6123 | 1969.1 | CT aspects of Single Radio Voice Call Continuity (SRVCC) in alerting phase (Stage 3) |  | 126d? | 2010-12-10 A | 2011-06-03 A | 100% | 2010-12-10 | 2011-06-03 | 126d? | finish no earlier than 2011-06-03 | C1 | 1008h | 1008h | aSRVCC | 26 | ZTE | li.shitao@zte.com.cn | Rel-10 | 50 | Frederic |  |  |  |  |  |
| 6124 | 1969.2 | Conformance test aspects SRVCC in alerting phase |  | 126d? | 2012-09-11 A | 2013-03-01 A | 100% | 2012-09-11 | 2013-03-01 | 126d? | finish no earlier than 2013-03-01 | R5 | 1008h | 1008h | aSRVCC-UEConTest | 29 | NTT DoCoMo | Takao.Shimizu.rp@nttdocomo.com | Rel-10 | 57 | Ingbert | aSRVCC-UEConTest | RP-130042 |  |  |  |
| 6125 | 1970 | **PCRF failure and restoration** |  | 71d? | 2010-12-10 A | 2011-03-18 A | 100% | 2010-12-10 | 2011-03-18 | 71d? |  | C4; C3 | 2130h | 2130h | PCRF_FR | 26 | NEC | Toshiyuki Tamura (tamurato@aj.jp.nec.com) | Rel-10 | 50 | Kimmo | PCRF_FR |  |  |  |  |
| 6126 | 1970.1 | CT4 part of PCRF failure and restoration |  | 71d? | 2010-12-10 A | 2011-03-18 A | 100% | 2010-12-10 | 2011-03-18 | 71d? | finish no earlier than 2011-03-18 | C4 | 568h | 568h | PCRF_FR | 26 | NEC | Toshiyuki Tamura (tamurato@aj.jp.nec.com) | Rel-10 | 50 | Kimmo |  |  |  |  |  |
| 6127 | 1970.2 | CT3 part of PCRF failure and restoration |  | 53.25d? | 2010-12-10 A | 2011-03-18 A | 100% | 2010-12-10 | 2011-03-18 | 53.25d? | start no earlier than 2010-12-10 | C3 | 426h | 426h | PCRF_FR | 26 | NEC | Toshiyuki Tamura (tamurato@aj.jp.nec.com) | Rel-10 | 50 | Adrian |  |  |  |  |  |
| 6128 | 1971 | Formalization of WLAN Files | milestone | 0d? | 2011-02-23 A | 2011-02-23 A | 100% | 2011-02-23 | 2011-03-18 | 0d? | start no earlier than 2011-03-16 | C1 |  |  | FoWF | 26 | Deutsche Telekom | dieter.jacobsohn@telekom.de | Rel-10 | 51 | Frederic | FoWF |  | WLAN |  |  |
| 6129 | 1972 | CS and IMS Interworking for CAT service - Early Session model |  | 58d? | 2011-03-16 A | 2011-06-03 A | 100% | 2011-03-16 | 2011-06-03 | 58d? |  | C3 | 464h | 464h | CIIC_ES | 26 | ZTE | li.shitao@zte.com.cn | Rel-10 | 51 | Adrian | CIIC_ES |  |  |  |  |
| 6130 | 1973 | EPC Node Restoration without Idle mode Signalling Reduction (ISR) activated |  | 3d? | 2011-03-16 A | 2011-03-18 A | 100% | 2011-03-16 | 2011-03-18 | 3d? | finish no earlier than 2011-03-18 | C4 | 24h | 24h | EPC_NR | 26 | Alcatel-Lucent | bruno.landais@alcatel-lucent.com | Rel-10 | 51 | Kimmo | EPC_NR |  |  |  |  |
| 6131 | 1974 | EPC Node Restoration with Idle mode Signalling Reduction (ISR) activated |  | 58d? | 2011-03-16 A | 2011-06-03 A | 100% | 2011-03-16 | 2011-06-03 | 58d? | finish no earlier than 2011-03-18 | C4 | 464h | 464h | EPC_NR_ISR | 26 | NEC | Toshiyuki Tamura (tamurato@aj.jp.nec.com) | Rel-10 | 51 | Kimmo | EPC_NR_ISR |  |  |  |  |
| 6132 | 1975 | Mobile Terminating Roaming Forwarding with pre-paging |  | 58d? | 2011-03-16 A | 2011-06-03 A | 100% | 2011-03-16 | 2011-06-03 | 58d? | finish no earlier than 2011-03-18 | C4 | 464h | 464h | MTRF | 26 | Ericsson | philip.hodges@ericsson.com | Rel-10 | 51 | Kimmo | MTRF |  |  |  |  |
| 6133 | 1976 | **UICC access to IMS Specification** |  | 58d? | 2011-03-16 A | 2011-06-03 A | 100% | 2011-03-16 | 2011-06-03 | 58d? |  | C6; C1 | 1416h | 1416h | IMS-UICC-S | 26 | Gemalto | Denis.Lheriteau@gemalto.com | Rel-10 | 51 | Xavier | IMS-UICC-S |  |  |  |  |
| 6134 | 1976.1 | CT6 part of UICC access to IMS Specification |  | 3d? | 2011-03-16 A | 2011-03-18 A | 100% | 2011-03-16 | 2011-03-18 | 3d? | start no earlier than 2011-03-16 | C6 | 24h | 24h | IMS-UICC-S | 26 | Gemalto | Denis.Lheriteau@gemalto.com | Rel-10 | 51 | Xavier |  |  |  |  |  |
| 6135 | 1976.2 | CT1 part of UICC access to IMS Specification |  | 58d? | 2011-03-16 A | 2011-06-03 A | 100% | 2011-03-16 | 2011-06-03 | 58d? | start no earlier than 2011-03-16 | C1 | 464h | 464h | IMS-UICC-S | 26 | Gemalto | Denis.Lheriteau@gemalto.com | Rel-10 | 51 | Frederic |  |  |  |  |  |
| 6136 | 1977 | Deleted - Testing for Terminal support of Rel-10 USIM, ISIM and USAT features |  | 463d? | 2012-03-05 A | 2013-12-03 A | 100% | 2012-03-05 | 2013-12-03 | 463d? | finish no earlier than 2013-06-14 | C6 | 3704h | 3704h | USIM_R10_Test | 28 | Gemalto | Denis.Praca@gemalto.com | Rel-10 | 55 | Xavier | USIM_R10_Test |  |  | PCG-32 | CP-62 |
| 6137 | 1978 | **CN aspects of Local Call Local Switch** |  | 472d? | 2009-05-29 A | 2011-03-18 A | 100% | 2009-05-29 | 2011-03-18 | 472d? |  | C4 | 13008h | 13008h | LCLS-CN | 23 | Vodafone | David.Hutton@vodafone.com | Rel-10 | 44 | Kimmo | LCLS-CN |  |  |  |  |
| 6138 | 1978.1 | TR on CN aspects of Local Call Local Switch |  | 341d? | 2009-05-29 A | 2010-09-16 A | 100% | 2009-05-29 | 2010-09-16 | 341d? | finish no earlier than 2010-09-17 | C4 | 2728h | 2728h | LCLS-CN | 23 | Vodafone | David.Hutton@vodafone.com | Rel-10 | 44 | Kimmo |  |  |  |  |  |
| 6139 | 1978.2 | Stage 2/3 for CN aspects of Local Call Local Switch |  | 131d? | 2010-09-17 A | 2011-03-18 A | 100% | 2010-09-17 | 2011-03-18 | 131d? | finish no earlier than 2011-03-18 | C4 | 1048h | 1048h | LCLS-CN | 25 | Vodafone | David.Hutton@vodafone.com | Rel-10 | 49 | Kimmo |  |  |  |  |  |
| 6140 | 1978.3 | Deleted - CT3 aspects of Local Call Local Switch |  | 341d? | 2009-05-29 A | 2010-09-16 A | 100% | 2009-05-29 | 2010-09-16 | 341d? | finish no earlier than 2010-09-17 | C3 | 2728h | 2728h | LCLS-CN | 23 | Vodafone | David.Hutton@vodafone.com | Rel-10 | 44 | Adrian |  |  |  | PCG-25 | CP-49 |
| 6141 | 1978.4 | Deleted - CT1 aspects of Local Call Local Switch |  | 341d? | 2009-05-29 A | 2010-09-16 A | 100% | 2009-05-29 | 2010-09-16 | 341d? | finish no earlier than 2010-09-17 | C1 | 2728h | 2728h | LCLS-CN | 23 | Vodafone | David.Hutton@vodafone.com | Rel-10 | 44 | Frederic |  |  |  | PCG-25 | CP-49 |
| 6142 | 1979 | Local Call Local Switch | milestone | 0d? | 2007-05-07 A | 2007-05-07 A | 100% | 2007-05-07 | 2011-05-20 | 1055.8d? |  | GP; G2 |  |  | LCLS | 22 | Huawei | wang_zhixi@huawei.com | Rel-10 | 41 | Paolo | LCLS |  |  |  |  |

Notes:
- 6118: Triggered by SA2 TR 23.856 Study on Single Radio Voice Call Continuity enhancements (FS_eSRVCC) UID_440049
- 6119: CP#51 completed / Impacted TSs and TRs: 24.229; 24.237
- 6120: CP#51 completed / Impacted TSs and TRs: 23.003; 23.008; 29.002; 29.230; 29.272; 29.305; 29.328; 29.329
- 6121: CP#58 completed / Impacted TSs and TRs: RFC 6809 (was draft-ietf-sipcore-proxy-feature)
- 6122: Builds on Rel-8 UID_390057 (IMS-Cont) TS 23.216 Stage 2. Provide Stage 3 for SRVCC PS-CS transfer of a call in alerting phase. Stage 2 TEI10 in TS 23.237 (6.3.2.1.4c/d, 6.3.2.1.7a/b)
- 6123: CP#52 completed / Impacted TSs and TRs: 24.008; 24.237
- 6124: RP#59 completed / Impacted TSs and TRs: 36.523-1; 36.523-2; 36.523-3; 34.229-1; 34.229-2; 34.229-3
- 6125: CP#51 completed. Triggered by CT3 TR 29.816 Study on Policy and Charging Rules Function (PCRF) failure and restoration (FS_PCRF-FR) UID_450013 / Impacted TSs and TRs: Stage 2/3 work
- 6126: CP#51 completed / Impacted TSs and TRs: Stage 2 23.007; Stage 3 29.230
- 6127: CP#51 completed / Impacted TSs and TRs: Stage 3 29.212; 29.213; 29.214; 29.215
- 6128: CP#51 completed. TS 24.235 for Info+Approval. Define the ME files as specified in 24.234 in OMA Device Management structure / Impacted TSs and TRs: Stage 3: 24.234; New 24.235
- 6129: CP#52 completed. Stage 1 in Rel-8 TS 22.182 Customized Alerting Tones (CAT) service. Stage 3 TS 24.182 defines 3 impl models: Gateway, Forking, Early Session. Specify missing CAT service interworking procedures btw CS & IMS networks / Impacted TSs and TRs: Stage 3 29.163; 29.235; 29.292
- 6130: CP#51 completed. Triggered by DRAFT TR 23.857 Study on EPC Nodes Restoration (FS_EPC_NR) UID_490014 / Impacted TSs and TRs: Stage 2/3: 23.007; 29.274
- 6131: CP#52 completed. Triggered by DRAFT TR 23.857 Study on EPC Nodes Restoration (FS_EPC_NR) UID_490014 / Impacted TSs and TRs: Stage 2/3: 23.007; 29.274
- 6132: CP#52 completed. Provides Stage 2/3 alternative solution to Mobile Terminating Roaming Retry to solve roaming events during paging, in particular to support CSFB. Hence, no new Stage 1 requirements exist / Impacted TSs and TRs: Stage 2/3: 23.012; 23.018; 23.116; 29.002
- 6133: CP#52 completed. Triggered by Rel-10 TR 31.828 Study on UICC access to IMS (FS_IMS-UICC) UID_480017. Specify mechanism in UICC and ME to make use of IMS functionality implemented in ME for case a) an ISIM is present b) no ISIM is present in UICC
- 6134: CP#51 completed / Impacted TSs and TRs: 31.102; 31.103; 31.111
- 6135: CP#52 completed / Impacted TSs and TRs: 24.229
- 6136: CP#62 stopped (at 70% completion 06/13). Testing for New featurES in CP-150Rel-10 specifications for USIM, ISIM applications and USIM Application Toolkit (USAT) in TS 31.102, 31.103, 31.111 / Impacted TSs and TRs: 31.121; 31.124; New 31.ABC (Conformance Testing of specific features)
- 6137: CP#51 completed / Impacted TSs and TRs: GERAN Stage 2/3
- 6138: CP#49 completed / Impacted TSs and TRs: new 23.889
- 6139: CP#51 completed / Impacted TSs and TRs: 23.003; 23.009; 23.205; 23.231; 29.002; 29.205; 29.232; new 23.284
- 6140: CP#49 stopped. Result of study TR 23.889: no CT3 specification impact
- 6141: CP#49 stopped. Result of study TR 23.889: no CT1 specification impact
- 6142: GP#50 completed. GP#41 WID approved / Impacted TSs and TRs: GERAN Stage 3: 48.008; 48.103

| ID | WBS | Task | Duration | Start | Finish | Complete | Baseline start | Baseline finish | Baseline duration | Constraint | Resources | Work | Actual work | Acronym | PCG approved | WI rapporteur name | Release | TSG approved | MCC resp | Acronym_3GU_Export | Status Report | Special Focus Doc |
| --- | --- | --- | --- | --- | --- | --- | --- | --- | --- | --- | --- | --- | --- | --- | --- | --- | --- | --- | --- | --- | --- | --- |
| 6143 | 1980 | **Tightened Link Level Performance Requirements for Single Antenna MS** | 659d? | 2010-09-03 A | 2013-03-01 A | 100% | 2010-09-03 | 2013-03-01 | 659d? |  | G1; G2; C1; G3new | 30856h | 30856h | TIGHTER | 25 | Renesas Mobile | Rel-10 | 46 | Paolo | TIGHTER |  |  |
| 6144 | 1980.1 | CT1 part for TIGHTER | 196d? | 2010-09-03 A | 2011-06-03 A | 100% | 2010-09-03 | 2011-06-03 | 196d? | finish no earlier than 2011-06-03 | C1 | 1568h | 1568h | TIGHTER | 25 | Renesas Mobile | Rel-10 | 46 | Frederic |  |  |  |
| 6145 | 1980.2 | TIGHTER Performance Requirements | 186d? | 2010-09-03 A | 2011-05-20 A | 100% | 2010-09-03 | 2011-05-20 | 186d? | finish no earlier than 2011-05-20 | G1; G2 | 2976h | 2976h | TIGHTER | 25 | Renesas Mobile | Rel-10 | 46 | Paolo |  |  |  |
| 6146 | 1980.3 | TIGHTER Testing | 654d? | 2010-09-08 A | 2013-03-01 A | 100% | 2010-09-08 | 2013-03-01 | 654d? | finish no earlier than 2013-03-01 | G3new | 5224h | 5224h | TIGHTER | 25 | Renesas Mobile | Rel-10 | 46 | Ingbert |  |  |  |
| 6147 | 1981 | **Support of Multi-Operator Core Network by GERAN** | 206d? | 2010-05-21 A | 2011-03-04 A | 100% | 2010-05-21 | 2011-03-04 | 206d? |  | G2; S2; C1 | 8392h | 8392h | MOCN-GERAN | 25 | Alcatel-Lucent | Rel-10 | 47 | Gert | MOCN-GERAN |  |  |
| 6148 | 1981.1 | Stage 2 for Support of Multi-Operator Core Network by GERAN | 150d? | 2010-05-21 A | 2010-12-16 A | 100% | 2010-05-21 | 2010-12-16 | 150d? | finish no earlier than 2010-12-15 | S2 | 1200h | 1200h | MOCN-GERAN | 25 | Alcatel-Lucent | Rel-10 | 47 | Maurice |  |  |  |
| 6149 | 1981.2 | CT1 part of Stage 3 for Support of Multi-Operator Core Network by GERAN | 146d? | 2010-05-21 A | 2010-12-10 A | 100% | 2010-05-21 | 2010-12-10 | 146d? | finish no earlier than 2010-12-10 | C1 | 1168h | 1168h | MOCN-GERAN | 25 | Alcatel-Lucent | Rel-10 | 47 | Frederic |  |  |  |
| 6150 | 1981.3 | GERAN2 part of Stage 3 for Support of Multi-Operator Core Network by GERAN | 135d? | 2010-08-30 A | 2011-03-04 A | 100% | 2010-08-30 | 2011-03-04 | 135d? | finish no earlier than 2011-03-04 | G2 | 1080h | 1080h | MOCN-GERAN | 25 | Alcatel-Lucent | Rel-10 | 47 | Gert |  |  |  |
| 6151 | 1982 | **Enhancements of Iur-g interface** | 196d? | 2010-09-03 A | 2011-06-03 A | 100% | 2010-09-03 | 2011-06-03 | 196d? |  | G2; R3 | 5752h | 5752h | eIurg | 25 | China Mobile, ZTE | Rel-10 | 47 | Gert | eIurg |  |  |
| 6152 | 1982.1 | GERAN part for Enhancements of Iur-g interface (Stage 2/3) | 131d? | 2010-09-03 A | 2011-03-04 A | 100% | 2010-09-03 | 2011-03-04 | 131d? | finish no earlier than 2011-03-04 | G2 | 1048h | 1048h | eIurg-GERAN | 25 | China Mobile, ZTE | Rel-10 | 47 | Gert | eIurg-GERAN |  |  |
| 6153 | 1982.2 | Core part: Enhancements of Iur-g interface (Stage 2/3) | 196d? | 2010-09-03 A | 2011-06-03 A | 100% | 2010-09-03 | 2011-06-03 | 196d? | finish no earlier than 2011-06-03 | R3 | 1568h | 1568h | eIurg-RAN | 25 | ZTE | Rel-10 | 49 | Juha | eIurg-RAN | RP-110526 |  |
| 6154 | 1983 | 1.28 Mcps TDD Repeater | 599d? | 2007-12-04 A | 2010-03-19 A | 100% | 2007-12-04 | 2010-03-19 | 599d? | finish no earlier than 2010-03-19 | R4 | 4792h | 4792h | RANimp-Repeaters1.28TDD | 21 | RITT | Rel-10 | 38 | Issam | RANimp-Repeaters1.28TDD | RP-100039 |  |
| 6155 | 1984 | 1.28 Mcps TDD Multi-carrier HSUPA | 321d? | 2009-09-18 A | 2010-12-10 A | 100% | 2009-09-18 | 2010-12-10 | 321d? | finish no earlier than 2010-12-10 | R1; R2; R3; R4 | 10272h | 10272h | TDD_MC_HSUPA | 23 | CATR | Rel-10 | 45 | Patrick | TDD_MC_HSUPA | RP-101079 |  |
| 6156 | 1985 | **1.28 Mcps TDD Home NodeB RF requirements** | 266d? | 2009-12-04 A | 2010-12-10 A | 100% | 2009-12-04 | 2010-12-10 | 266d? |  | R4 | 5304h | 5304h | HNB_LCRTDD_RF | 24 | TD Tech | Rel-10 | 46 | Issam | HNB_LCRTDD_RF |  | HNB |
| 6157 | 1985.1 | Core part: 1.28Mcps TDD Home NodeB RF requirements | 131d? | 2009-12-04 A | 2010-06-04 A | 100% | 2009-12-04 | 2010-06-04 | 131d? | finish no earlier than 2010-12-10 | R4 | 1048h | 1048h | HNB_LCRTDD_RF-Core | 24 | TD Tech | Rel-10 | 46 | Issam | HNB_LCRTDD_RF-Core | RP-100446 | HNB |
| 6158 | 1985.2 | Perf. part: 1.28Mcps TDD Home NodeB RF requirements | 266d? | 2009-12-04 A | 2010-12-10 A | 100% | 2009-12-04 | 2010-12-10 | 266d? | finish no earlier than 2010-12-10 | R4 | 2128h | 2128h | HNB_LCRTDD_RF-Perf | 24 | TD Tech | Rel-10 | 46 | Issam | HNB_LCRTDD_RF-Perf | RP-101081 | HNB |
| 6159 | 1986 | **Multi-User Multiple-Input and Multiple-Output (MU-MIMO) for 1.28Mcps TDD** | 316d? | 2010-03-19 A | 2011-06-03 A | 100% | 2010-03-19 | 2011-06-03 | 316d? |  | R1; R2; R3; R4 | 17224h | 17224h | MUMIMO_LCR_TDD | 24 | CATT | Rel-10 | 47 | Patrick | MUMIMO_LCR_TDD |  |  |
| 6160 | 1986.1 | Core part: MU-MIMO for 1.28Mcps TDD | 191d? | 2010-03-19 A | 2010-12-10 A | 100% | 2010-03-19 | 2010-12-10 | 191d? | finish no earlier than 2010-12-10 | R1; R2; R3 | 4584h | 4584h | MUMIMO_LCR_TDD-Core | 24 | CATT | Rel-10 | 47 | Patrick | MUMIMO_LCR_TDD-Core | RP-101085 |  |
| 6161 | 1986.2 | Perf. part: MU-MIMO for 1.28Mcps TDD | 316d? | 2010-03-19 A | 2011-06-03 A | 100% | 2010-03-19 | 2011-06-03 | 316d? | finish no earlier than 2011-06-03 | R4 | 2528h | 2528h | MUMIMO_LCR_TDD-Perf | 24 | CATT | Rel-10 | 47 | Issam | MUMIMO_LCR_TDD-Perf | RP-110520 |  |
| 6162 | 1987 | **AGNSS Minimum Performance for UTRAN** | 523d? | 2009-09-18 A | 2011-09-16 A | 100% | 2009-09-18 | 2011-09-16 | 523d? |  | R4; R5 | 13624h | 13624h | AGNSSPerf_UTRAN | 23 | Thales | Rel-10 | 45 | Issam | AGNSSPerf_UTRAN |  |  |
| 6163 | 1987.1 | AGNSS Minimum Performance Specification Development | 321d? | 2009-09-18 A | 2010-12-10 A | 100% | 2009-09-18 | 2010-12-10 | 321d? | finish no earlier than 2010-12-10 | R4 | 2568h | 2568h | AGNSSPerf_UTRAN | 23 | Thales | Rel-10 | 45 | Issam | AGNSSPerf_UTRAN | RP-101078 |  |
| 6164 | 1987.2 | AGNSS test case development for UMTS | 336d? | 2010-06-04 A | 2011-09-16 A | 100% | 2010-06-04 | 2011-09-16 | 336d? | finish no earlier than 2011-09-16 | R5 | 2688h | 2688h | AGNSSPerf_UTRAN | 25 | Thales | Rel-10 | 48 | Ingbert | AGNSSPerf_UTRAN | RP-110979 |  |
| 6165 | 1988 | **Inclusion of RF Pattern Matching Technologies as positioning method in the UTRAN** | 336d? | 2009-12-04 A | 2011-03-18 A | 100% | 2009-12-04 | 2011-03-18 | 336d? |  | R2; R3 | 10752h | 10752h | LCS_UMTS_RFPMT | 24 | Polaris Wireless | Rel-10 | 46 | Yong-Jun | LCS_UMTS_RFPMT | RP-110048 |  |
| 6166 | 1988.1 | Core part: Inclusion of RF Pattern Matching Technologies as positioning method in the UTRAN | 336d? | 2009-12-04 A | 2011-03-18 A | 100% | 2009-12-04 | 2011-03-18 | 336d? | finish no earlier than 2011-03-18 | R2; R3 | 5376h | 5376h | LCS_UMTS_RFPMT-Core | 24 | Polaris Wireless | Rel-10 | 46 | Yong-Jun | LCS_UMTS_RFPMT-Core | RP-110048 |  |

Notes:
- 6143: GP#46 approved WID / Impacted TSs and TRs: GERAN / WI rapporteur e-mail: carsten.juncker@renesasmobile.com
- 6144: CP#52 completed / Impacted TSs and TRs: 24.008 / WI rapporteur e-mail: marko.niemi@renesasmobile.com
- 6145: GP#50 completed / Impacted TSs and TRs: 45.005; 45.015 / WI rapporteur e-mail: carsten.juncker@renesasmobile.com
- 6146: GP#57 completed / Impacted TSs and TRs: 51.010 / WI rapporteur e-mail: carsten.juncker@renesasmobile.com
- 6147: GP#47 approved WID. 900 MHz spectrum re-farming to other RATs lead operators to reduce GSM capacity and therefore share their GSM networks. Hence the need for the most suitable (GE)RAN sharing method / Impacted TSs and TRs: GERAN / WI rapporteur e-mail: michel.robert@alcatel-lucent.com
- 6148: SP#50 completed / Impacted TSs and TRs: 23.251 / WI rapporteur e-mail: michel.robert@alcatel-lucent.com
- 6149: CP#50 completed / Impacted TSs and TRs: 24.008 CR#1644 / WI rapporteur e-mail: michel.robert@alcatel-lucent.com
- 6150: GP#49 completed / Impacted TSs and TRs: 48.008 CR#0325; 48.018 CR#0303 / WI rapporteur e-mail: michel.robert@alcatel-lucent.com
- 6151: GP#47 approved WID / Impacted TSs and TRs: GERAN.UTRA / WI rapporteur e-mail: Ms Juan Deng (dengjuan@chinamobile.com), Xinhui Wang (wangxinhui@zte.com.cn)
- 6152: GP#49 completed. GP#48 updated WID GP-101659=>GP-101758 (restricting the scope to GERAN BSC and TD-SCDMA RNC only). GP#47 approved WID / Impacted TSs and TRs: 43.130; 48.008 / WI rapporteur e-mail: Ms Juan Deng (dengjuan@chinamobile.com), Xinhui Wang (wangxinhui@zte.com.cn)
- 6153: RP#52 completed / Impacted TSs and TRs: UTRA Stage 2 (25.401; 25.420); Stage 3 (25.423) / WI rapporteur e-mail: Liu Junqiang (liu.junqiang@zte.com.cn)
- 6154: RP#47 completed / Impacted TSs and TRs: UTRA 25.113; New 25.116; 25.153 (testing) / WI rapporteur e-mail: qinyan@chinattl.com
- 6155: RP#50 completed / Impacted TSs and TRs: UTRA 25.102; 25.105; 25.123; 25.221; 25.222; 25.223; 25.224; 25.225; 25.306; 25.319; 25.321; 25.331; 25.423; 25.427; 25.433 / WI rapporteur e-mail: Aihui Song (songaihui@mail.ritt.com.cn)
- 6156: RP#50 completed. Triggered by FS_RAN-HNBLCRTDD UID_410016 Study on 1.28 Mcps TDD Home NodeB (TR 25.866) / Impacted TSs and TRs: UTRA / WI rapporteur e-mail: Li Rong (lirong@td-tech.com)
- 6157: RP#48 completed / Impacted TSs and TRs: 25.105 / WI rapporteur e-mail: Li Rong (lirong@td-tech.com)
- 6158: RP#50 completed. TR 25.968 v100 for Approval / Impacted TSs and TRs: 25.142; new 25.968 / WI rapporteur e-mail: Li Rong (lirong@td-tech.com)
- 6159: RP#52 completed / Impacted TSs and TRs: UTRA / WI rapporteur e-mail: Yanping Xing (xingyanping@datangmobile.cn)
- 6160: RP#50 completed / Impacted TSs and TRs: 25.221; 25.222; 25.224; 25.306; 25.308; 25.319; 25.331; 25.423; 25.425; 25.433; 25.435 / WI rapporteur e-mail: Yanping Xing (xingyanping@datangmobile.cn)
- 6161: RP#52 completed / Impacted TSs and TRs: 25.102; 25.105; 25.142 / WI rapporteur e-mail: Sanjun Feng (fengsanjun@datangmobile.cn)
- 6162: RP#53 completed. Triggered by Rel-7 UID_20050 (GNSS in UTRAN) and Rel-8 UID_400051 (Support for Additional NSS). Linked to GERAN Rel-9 UID_38002 (AGNSS Performances and Testing Procedures) / Impacted TSs and TRs: UTRA / WI rapporteur e-mail: Michel.monnerat@thalesaleniaspace.com
- 6163: RP#50 completed / Impacted TSs and TRs: new 25.172 / WI rapporteur e-mail: Michel.monnerat@thalesaleniaspace.com
- 6164: RP#53 completed / Impacted TSs and TRs: 34.108; 34.109; 34.123-1; 34.123-2; 34.123-3; 36.37.571-5; new 34.172 / WI rapporteur e-mail: Michel.monnerat@thalesaleniaspace.com
- 6165: RP#51 completed. Triggered by Study UID_380079 Evaluation of the inclusion of Path Loss Based Technology in the UTRAN (25.907) / Impacted TSs and TRs: UTRA / WI rapporteur e-mail: Norman Shaw (nshaw@polariswireless.com)
- 6166: RP#51 completed / Impacted TSs and TRs: 25.305; 25.453 / WI rapporteur e-mail: Norman Shaw (nshaw@polariswireless.com)

| ID | WBS | Task | Duration | Start | Finish | Complete | Baseline start | Baseline finish | Baseline duration | Constraint | Resources | Work | Actual work | Acronym | PCG approved | WI rapporteur name | WI rapporteur e-mail | Release | TSG approved | MCC resp | Acronym_3GU_Export | Status Report | PCG stopped | TSG stopped | Special Focus Doc |
| --- | --- | --- | --- | --- | --- | --- | --- | --- | --- | --- | --- | --- | --- | --- | --- | --- | --- | --- | --- | --- | --- | --- | --- | --- | --- |
| 6167 | 1989 | **Four carrier HSDPA** | 992d? | 2009-12-04 A | 2013-09-06 A | 100% | 2009-12-04 | 2013-09-06 | 992d? |  | R1; R2; R3; R4; R5 | 57872h | 57872h | 4C_HSDPA | 24 | Qualcomm | Arjun Bharadwaj (arjunb@qualcomm.com) | Rel-10 | 46 | Patrick | 4C_HSDPA |  |  |  |  |
| 6168 | 1989.1 | Core part: Four carrier HSDPA | 336d? | 2009-12-04 A | 2011-03-18 A | 100% | 2009-12-04 | 2011-03-18 | 336d? | finish no earlier than 2011-03-18 | R1; R2; R3; R4 | 10752h | 10752h | 4C_HSDPA-Core | 24 | Qualcomm | Arjun Bharadwaj (arjunb@qualcomm.com) | Rel-10 | 46 | Patrick | 4C_HSDPA-Core | RP-110046 |  |  |  |
| 6169 | 1989.2 | Perf. part: Four carrier HSDPA | 466d? | 2009-12-04 A | 2011-09-16 A | 100% | 2009-12-04 | 2011-09-16 | 466d? | finish no earlier than 2011-09-16 | R4 | 3728h | 3728h | 4C_HSDPA-Perf | 24 | Qualcomm | Arjun Bharadwaj (arjunb@qualcomm.com) | Rel-10 | 46 | Issam | 4C_HSDPA-Perf | RP-110986 |  |  |  |
| 6170 | 1989.3 | Test part: Four carrier HSDPA | 464d? | 2011-12-02 A | 2013-09-06 A | 100% | 2011-12-02 | 2013-09-06 | 464d? | finish no earlier than 2013-09-06 | R5 | 3712h | 3712h | 4C_HSDPA-UEConTest | 28 | Qualcomm | Shubhang Vora (svora@qualcomm.com) | Rel-10 | 54 | Ingbert | 4C_HSDPA-UEConTest | RP-130940 |  |  |  |
| 6171 | 1990 | **Performance Requirements for two-antenna 1.28Mcps TDD Type 1 and Type 2 UE receiver** | 316d? | 2010-03-19 A | 2011-06-03 A | 100% | 2010-03-19 | 2011-06-03 | 316d? |  | R4 | 5504h | 5504h | 2ant_UE_LCR_TDD | 24 | TD Tech | dafei.wang@td-tech.com | Rel-10 | 47 | Issam | 2ant_UE_LCR_TDD |  |  |  |  |
| 6172 | 1990.1 | Core part: Performance Requirements for two-antenna 1.28Mcps TDD Type 1 and Type 2 UE receiver | 56d? | 2010-03-19 A | 2010-06-04 A | 100% | 2010-03-19 | 2010-06-04 | 56d? | finish no earlier than 2010-06-04 | R4 | 448h | 448h | 2ant_UE_LCR_TDD-Core | 24 | TD Tech | dafei.wang@td-tech.com | Rel-10 | 47 | Issam | 2ant_UE_LCR_TDD-Core | RP-100454 |  |  |  |
| 6173 | 1990.2 | Perf. part: Performance Requirements for two-antenna 1.28Mcps TDD Type 1 and Type 2 UE receiver | 316d? | 2010-03-19 A | 2011-06-03 A | 100% | 2010-03-19 | 2011-06-03 | 316d? | finish no earlier than 2011-06-03 | R4 | 2528h | 2528h | 2ant_UE_LCR_TDD-Perf | 24 | TD Tech | dafei.wang@td-tech.com | Rel-10 | 47 | Issam | 2ant_UE_LCR_TDD-Perf | RP-110521 |  |  |  |
| 6174 | 1991 | **Automatic Neighbour Relation (ANR) for UTRAN** | 663d? | 2010-06-04 A | 2012-12-07 A | 100% | 2010-06-04 | 2012-12-07 | 663d? |  | R3; R2; R5 | 22672h | 22672h | ANR_UTRAN | 25 | ZTE | Zhai.hengxing@zte.com.cn | Rel-10 | 48 | Juha | ANR_UTRAN |  |  |  |  |
| 6175 | 1991.1 | Core part: Automatic Neighbour Relation (ANR) for UTRAN | 261d? | 2010-06-04 A | 2011-06-03 A | 100% | 2010-06-04 | 2011-06-03 | 261d? | finish no earlier than 2011-06-03 | R3; R2 | 4176h | 4176h | ANR_UTRAN-Core | 25 | ZTE | Zhai.hengxing@zte.com.cn | Rel-10 | 48 | Juha | ANR_UTRAN-Core | RP-110522 |  |  |  |
| 6176 | 1991.2 | Test part: Automatic Neighbour Relation (ANR) for UTRAN | 323d? | 2011-09-19 A | 2012-12-07 A | 100% | 2011-09-19 | 2012-12-07 | 323d? | finish no earlier than 2012-12-07 | R5 | 2584h | 2584h | ANR_UTRAN-UEConTest | 27 | Ericsson | leif.mattisson@ericsson.com | Rel-10 | 53 | Ingbert | ANR_UTRAN-UEConTest | RP-121529 |  |  |  |
| 6177 | 1992 | **Support of New Band Combinations for Dual-Band Dual Cell HSDPA** | 261d? | 2010-06-04 A | 2011-06-03 A | 100% | 2010-06-04 | 2011-06-03 | 261d? |  | R4; R2 | 9568h | 9568h | DB_DC_HSDPA | 25 | AT&T | Vince Spatafora (vs5785@att.com) | Rel-10 | 48 | Issam | DB_DC_HSDPA |  |  |  |  |
| 6178 | 1992.1 | Core part: Support of New Band Combinations for Dual-Band Dual Cell HSDPA | 261d? | 2010-06-04 A | 2011-06-03 A | 100% | 2010-06-04 | 2011-06-03 | 261d? | finish no earlier than 2011-06-03 | R4; R2 | 4176h | 4176h | DB_DC_HSDPA-Core | 25 | AT&T | Vince Spatafora (vs5785@att.com) | Rel-10 | 48 | Issam | DB_DC_HSDPA-Core | RP-110523 |  |  |  |
| 6179 | 1992.2 | Deleted - Perf. part: Support of New Band Combinations for Dual-Band Dual Cell HSDPA | 76d? | 2010-06-04 A | 2010-09-17 A | 100% | 2010-06-04 | 2010-09-17 | 76d? | finish no earlier than 2010-09-17 | R4; R2 | 1216h | 1216h | DB_DC_HSDPA-Perf | 25 | AT&T | Vince Spatafora (vs5785@att.com) | Rel-10 | 48 | Issam | DB_DC_HSDPA-Perf | RP-100759 | PCG-25 | RP-49 |  |
| 6180 | 1993 | **MIMO operation with non-MIMO coexistence in HSDPA** | 459d? | 2010-06-04 A | 2012-03-02 A | 100% | 2010-06-04 | 2012-03-02 | 459d? |  | R4; R5 | 12936h | 12936h | MIMO_HSDPA | 25 | Qualcomm | Heechoon Lee | Rel-10 | 48 | Issam | MIMO_HSDPA |  |  |  |  |
| 6181 | 1993.1 | Core part: MIMO operation with non-MIMO coexistence in HSDPA | 186d? | 2010-09-17 A | 2011-06-03 A | 100% | 2010-09-17 | 2011-06-03 | 186d? | finish no earlier than 2011-06-03 | R4 | 1488h | 1488h | MIMO_HSDPA-Core | 25 | Qualcomm | Heechoon Lee | Rel-10 | 49 | Issam | MIMO_HSDPA-Core | RP-110524 |  |  |  |
| 6182 | 1993.2 | Perf. part: MIMO operation with non-MIMO coexistence in HSDPA | 261d? | 2010-06-04 A | 2011-06-03 A | 100% | 2010-06-04 | 2011-06-03 | 261d? | finish no earlier than 2011-06-03 | R4 | 2088h | 2088h | MIMO_HSDPA-Perf | 25 | Qualcomm | Heechoon Lee | Rel-10 | 48 | Issam | MIMO_HSDPA-Perf | RP-110525 |  |  |  |
| 6183 | 1993.3 | Test part: MIMO operation with non-MIMO coexistence in HSDPA | 252d? | 2011-03-18 A | 2012-03-02 A | 100% | 2011-03-18 | 2012-03-02 | 252d? | finish no earlier than 2012-03-02 | R5 | 2016h | 2016h | MIMO_HSDPA-UEConTest | 26 | Qualcomm | Shubhang Vora (svora@qualcomm.com) | Rel-10 | 51 | Ingbert | MIMO_HSDPA-UEConTest | RP-120042 |  |  |  |
| 6184 | 1994 | Interfrequency detected set measurements for UMTS | 61d? | 2010-09-17 A | 2010-12-10 A | 100% | 2010-09-17 | 2010-12-10 | 61d? | finish no earlier than 2010-12-10 | R2; R4 | 976h | 976h | Interf_dset_meas_UMTS | 25 | Nokia | Chris.callender@nokia.com | Rel-10 | 49 | Yong-Jun | Interf_dset_meas_UMTS | RP-101093 |  |  |  |
| 6185 | 1995 | **Carrier Aggregation for LTE** | 793d? | 2009-12-04 A | 2012-12-07 A | 100% | 2009-12-04 | 2012-12-07 | 793d? |  | R1; R2; R3; R4; R5 | 51024h | 51024h | LTE_CA | 24 | Nokia | Asbjorn.grovlen@nokia.com | Rel-10 | 46 | Patrick | LTE_CA |  |  |  | CA |
| 6186 | 1995.1 | Core part: Carrier Aggregation for LTE | 391d? | 2009-12-04 A | 2011-06-03 A | 100% | 2009-12-04 | 2011-06-03 | 391d? | finish no earlier than 2011-06-03 | R1; R2; R3; R4 | 12512h | 12512h | LTE_CA-Core | 24 | Nokia | lars.e.lindh@nokia.com | Rel-10 | 46 | Patrick | LTE_CA-Core | RP-110535 |  |  | CA |
| 6187 | 1995.2 | Perf. part: Carrier Aggregation for LTE | 528d? | 2009-12-04 A | 2011-12-09 A | 100% | 2009-12-04 | 2011-12-09 | 528d? | finish no earlier than 2011-12-09 | R4 | 4224h | 4224h | LTE_CA-Perf | 24 | Nokia | lars.e.lindh@nokia.com | Rel-10 | 46 | Issam | LTE_CA-Perf | RP-111452 |  |  | CA |
| 6188 | 1995.3 | Test part: Carrier Aggregation for LTE | 321d? | 2011-09-19 A | 2012-12-07 A | 100% | 2011-09-19 | 2012-12-07 | 321d? | finish no earlier than 2012-12-07 | R5 | 2568h | 2568h | LTE_CA-UEConTest | 27 | Nokia | jussi.kuusisto@nokia.com | Rel-10 | 53 | Ingbert | LTE_CA-UEConTest | RP-121528 |  |  | CA |
| 6189 | 1996 | **Enhanced Downlink Multiple Antenna Transmission for LTE** | 930d? | 2009-12-04 A | 2013-06-14 A | 100% | 2009-12-04 | 2013-06-14 | 930d? |  | R1; R2; R4; R5 | 44624h | 44624h | LTE_eDL_MIMO | 24 | NTT DoCoMo | Hidekazu Taoka (taoka@nttdocomo.com) | Rel-10 | 46 | Patrick | LTE_eDL_MIMO |  |  |  |  |
| 6190 | 1996.1 | Core part: Enhanced Downlink Multiple Antenna Transmission for LTE | 336d? | 2009-12-04 A | 2011-03-18 A | 100% | 2009-12-04 | 2011-03-18 | 336d? | finish no earlier than 2011-03-18 | R1; R2; R4 | 8064h | 8064h | LTE_eDL_MIMO-Core | 24 | NTT DoCoMo | Hidekazu Taoka (taoka@nttdocomo.com) | Rel-10 | 46 | Patrick | LTE_eDL_MIMO-Core | RP-110067 |  |  |  |
| 6191 | 1996.2 | Perf. part: Enhanced Downlink Multiple Antenna Transmission for LTE | 589d? | 2009-12-04 A | 2012-03-02 A | 100% | 2009-12-04 | 2012-03-02 | 589d? | finish no earlier than 2012-03-02 | R4 | 4712h | 4712h | LTE_eDL_MIMO-Perf | 24 | NTT DoCoMo | Hidekazu Taoka (taoka@nttdocomo.com) | Rel-10 | 46 | Issam | LTE_eDL_MIMO-Perf | RP-120053 |  |  |  |
| 6192 | 1996.3 | Test part: Enhanced Downlink Multiple Antenna Transmission for LTE | 261d? | 2012-06-18 A | 2013-06-14 A | 100% | 2012-06-18 | 2013-06-14 | 261d? | finish no earlier than 2013-06-14 | R5 | 2088h | 2088h | LTE_eDL_MIMO-UEConTest | 29 | ZTE | Carolyn Taylor (carolyn.tayl@zte.com.cn) | Rel-10 | 56 | Ingbert | LTE_eDL_MIMO-UEConTest | RP-130464 |  |  |  |

Notes:
- 6167: RP#53 completed / Impacted TSs and TRs: UTRA
- 6168: RP#51 completed. RP#52 TR 25.864 v200 for Approval / Impacted TSs and TRs: 25.101; 25.104; 25.133; 25.211; 25.212; 25.213; 25.214; 25.215; 25.308; 25.331; 25.423; 25.433; 26.306; new 25.864
- 6169: RP#53 completed / Impacted TSs and TRs: 25.101; 25.104; 25.133; 25.141
- 6170: RP#61 completed / Impacted TSs and TRs: 34.108; 34.121-1; 34.121-2; 34.123-1; 34.123-2; 34.123-3
- 6171: Stage 3. RP#52 completed / Impacted TSs and TRs: UTRA
- 6172: RP#48 completed / Impacted TSs and TRs: 25.102
- 6173: RP#52 completed / Impacted TSs and TRs: 25.102
- 6174: RP#52 Core completed. Automatic Neighbour Relation (ANR) function for UTRAN relieves operators from the burden of manually managing the Neighbour cell Relations (NRs) / Impacted TSs and TRs: UTRA
- 6175: RP#52 completed / Impacted TSs and TRs: 25.331; 25.413; 25.423; new 25.484 (Stage 2)
- 6176: RP#58 completed / Impacted TSs and TRs: 34.108; 34.123-1; 34.123-2; 34.123-3
- 6177: RP#52 completed. Rel-9 Dual-Band Dual-Cell HSDPA (UID_430015 Support for different bands for Dual-Cell HSDPA) has one combination per region in principle. This work adds additional combinations: Band I and XI (Region 3) and Band II and V (Region 2) / Impacted TSs and TRs: UTRA
- 6178: RP#52 completed. RP#62 existing TS 25.317 replaced by new TS 25.327 / Impacted TSs and TRs: 25.101; 25.104; 25.141; 25.317 replaced by new 25.327
- 6179: RP#49 stopped (Reason: no need for Performance work) / Impacted TSs and TRs: 25.101; 25.104; 25.141; 25.317
- 6180: RP#52 completed. RP#49 updated WID RP-100687=>RP-100993 (changed Title: MIMO Testing in HSDPA => MIMO operation with non-MIMO coexistence in HSDPA) / Impacted TSs and TRs: UTRA
- 6181: RP#52 completed / Impacted TSs and TRs: 25.104
- 6182: RP#52 completed / Impacted TSs and TRs: 25.101; 25.141
- 6183: RP#55 completed / Impacted TSs and TRs: 34.108; 34.121-1; 34.121-2; 34.123-1; 34.123-2; 34.123-3
- 6184: RP#50 completed / Impacted TSs and TRs: UTRA 25.133; 25.331
- 6185: - / Impacted TSs and TRs: LTE
- 6186: RP#52 completed. RP#56 new RAN4 TR (36.807, 36.808) v200 for Approval / Impacted TSs and TRs: 36.101; 36.104; 36.133; 36.211; 36.212; 36.213; 36.300; 36.302; 36.306; 36.321; 36.331; 36.413; 36.423; 37.104; new RAN4 (36.807; 36.808)
- 6187: RP#54 completed / Impacted TSs and TRs: 36.101; 36.104; 36.133; 36.141; 37.141
- 6188: RP#58 completed / Impacted TSs and TRs: 36.508; 36.521-1; 36.521-2; 36.521-3; 36.523-1; 36.523-2; 36.523-3; 37.571-1; 37.571-3; 37.571-5
- 6189: - / Impacted TSs and TRs: LTE
- 6190: RP#51 completed. RP#56 new RAN4 TR 36.807 v200 for Approval / Impacted TSs and TRs: 36.101; 36.104; 36.133; 36.201; 36.211; 36.212; 36.213; 36.300; 36.306; 36.321; 36.331; new RAN4 36.807
- 6191: RP#55 completed / Impacted TSs and TRs: 36.101; 36.104; 36.133; 36.141
- 6192: RP#60 completed. Testing for 36.101, 36.133 / Impacted TSs and TRs: 36.508; 36.521-1; 36.521-2

| ID | WBS | Task | Duration | Start | Finish | Complete | Baseline start | Baseline finish | Baseline duration | Constraint | Resources | Work | Actual work | Acronym | PCG approved | WI rapporteur name | WI rapporteur e-mail | Release | TSG approved | MCC resp | Acronym_3GU_Export | Status Report | PCG stopped | TSG stopped |
| --- | --- | --- | --- | --- | --- | --- | --- | --- | --- | --- | --- | --- | --- | --- | --- | --- | --- | --- | --- | --- | --- | --- | --- | --- |
| 6193 | 1997 | **Uplink Multiple Antenna Transmission for LTE** | 3445d? | 2000-01-03 A | 2013-03-01 A | 100% | 2000-01-03 | 2013-03-01 | 3445d? |  | R1; R2; R4; R5 | 125976h | 125976h | LTE_UL_MIMO | 24 | Huawei | Mattias.wennstrom@huawei.com | Rel-10 | 46 | Patrick | LTE_UL_MIMO |  |  |  |
| 6194 | 1997.1 | Core part: UL multiple antenna transmission for LTE | 391d? | 2000-01-03 A | 2001-06-29 A | 100% | 2000-01-03 | 2001-06-29 | 391d? |  | R1; R2; R4 | 9384h | 9384h | LTE_UL_MIMO-Core | 24 | Huawei | Mattias.wennstrom@huawei.com | Rel-10 | 46 | Patrick | LTE_UL_MIMO-Core | RP-110537 |  |  |
| 6195 | 1997.2 | Perf. part: UL multiple antenna transmission for LTE | 466d? | 2009-12-04 A | 2011-09-16 A | 100% | 2009-12-04 | 2011-09-16 | 466d? | finish no earlier than 2011-09-16 | R4 | 3728h | 3728h | LTE_UL_MIMO-Perf | 24 | Huawei | Mattias.wennstrom@huawei.com | Rel-10 | 46 | Issam | LTE_UL_MIMO-Perf | RP-110992 |  |  |
| 6196 | 1997.3 | Test part: UL multiple antenna transmission for LTE | 328d? | 2011-12-02 A | 2013-03-01 A | 100% | 2011-12-02 | 2013-03-01 | 328d? | finish no earlier than 2013-03-01 | R5 | 2624h | 2624h | LTE_UL_MIMO-UEConTest | 28 | Huawei | Zhang Xin (suzanna.zhang@huawei.com) | Rel-10 | 54 | Ingbert | LTE_UL_MIMO-UEConTest | RP-130038 |  |  |
| 6197 | 1998 | **Relays for LTE** | 394d? | 2009-12-04 A | 2011-06-08 A | 100% | 2009-12-04 | 2011-06-08 | 394d? |  | R1; R2; R4; S2; S3; C4; C6 | 36856h | 36856h | LTE_Relay | 24 | Ericsson | christian.hoymann@ericsson.com | Rel-10 | 46 | Patrick | LTE_Relay |  |  |  |
| 6198 | 1998.1 | Core part: Relays for LTE | 391d? | 2009-12-04 A | 2011-06-03 A | 100% | 2009-12-04 | 2011-06-03 | 391d? | finish no earlier than 2011-06-03 | R1; R2; R4 | 9384h | 9384h | LTE_Relay-Core | 24 | Ericsson | christian.hoymann@ericsson.com | Rel-10 | 46 | Patrick | LTE_Relay-Core | RP-110540 |  |  |
| 6199 | 1998.2 | Deleted - Perf. part: Relays for LTE | 391d? | 2009-12-04 A | 2011-06-03 A | 100% | 2009-12-04 | 2011-06-03 | 391d? | finish no earlier than 2011-09-16 | R4 | 3128h | 3128h | LTE_Relay-Perf | 24 | Ericsson | christian.hoymann@ericsson.com | Rel-10 | 46 | Issam | LTE_Relay-Perf | RP-110541 | PCG-27 | RP-52 |
| 6200 | 1998.3 | Stage 2 for Relays for LTE | 3d? | 2011-06-06 A | 2011-06-08 A | 100% | 2011-06-06 | 2011-06-08 | 3d? | start no earlier than 2011-06-06 | S2 | 24h | 24h | LTE_Relay | 27 | Vodafone | chris.pudney@vodafone.com | Rel-10 | 52 | Maurice | LTE_Relay |  |  |  |
| 6201 | 1998.4 | **LTE Relay Nodes Security** | 69d? | 2010-12-16 A | 2011-03-22 A | 100% | 2010-12-16 | 2011-03-22 | 69d? |  | S3; C6 | 2232h | 2232h | LTE_Relay-Sec | 26 | Qualcomm | Adrian Escott (aescott@qualcomm.com) | Rel-10 | 50 | Mirko | LTE_Relay-Sec |  |  |  |
| 6202 | 1998.4.1 | TR on LTE Relay Nodes Security | 69d? | 2010-12-16 A | 2011-03-22 A | 100% | 2010-12-16 | 2011-03-22 | 69d? | finish no earlier than 2011-03-23 | S3 | 552h | 552h | LTE_Relay-Sec | 26 | Qualcomm | Adrian Escott (aescott@qualcomm.com) | Rel-10 | 50 | Mirko |  |  |  |  |
| 6203 | 1998.4.2 | Security for LTE Relay Nodes (Stage 2) | 69d? | 2010-12-16 A | 2011-03-22 A | 100% | 2010-12-16 | 2011-03-22 | 69d? | finish no earlier than 2011-03-23 | S3 | 552h | 552h | LTE_Relay-Sec | 26 | Qualcomm | Adrian Escott (aescott@qualcomm.com) | Rel-10 | 50 | Mirko |  |  |  |  |
| 6204 | 1998.4.3 | CT6 aspects of LTE Relay Node Security | 3d? | 2011-03-16 A | 2011-03-18 A | 100% | 2011-03-16 | 2011-03-18 | 3d? | start no earlier than 2011-03-16 | C6 | 24h | 24h | LTE_Relay-Sec | 26 | n/a | n/a | Rel-10 | 51 | Xavier |  |  |  |  |
| 6205 | 1998.5 | Core Network Impacts for Relay Nodes | 3d? | 2011-03-16 A | 2011-03-18 A | 100% | 2011-03-16 | 2011-03-18 | 3d? | finish no earlier than 2011-03-18 | C4 | 24h | 24h | LTE_Relay-CN | 26 | Vodafone | David.Hutton@vodafone.com | Rel-10 | 51 | Kimmo | LTE_Relay-CN |  |  |  |
| 6206 | 1999 | **Enhanced Inter-Cell Interference Control (ICIC) for non-Carrier Aggregation (CA) based deployments of heterogeneous networks for LTE** | 1119d? | 2010-03-19 A | 2014-06-13 A | 100% | 2010-03-19 | 2014-06-13 | 1119d? |  | R1; R2; R3; R4; R5 | 64384h | 64384h | eICIC_LTE | 24 | China Mobile | Xiaodong XU (xuxiaodong@chinamobile.com) | Rel-10 | 47 | Patrick | eICIC_LTE |  |  |  |
| 6207 | 1999.1 | Core part: Enhanced Inter-Cell Interference Control (ICIC) for non-Carrier Aggregation (CA) based deployments of heterogeneous networks for LTE | 316d? | 2010-03-19 A | 2011-06-03 A | 100% | 2010-03-19 | 2011-06-03 | 316d? | finish no earlier than 2011-06-03 | R1; R2; R3; R4 | 10112h | 10112h | eICIC_LTE-Core | 24 | China Mobile | Xiaodong XU (xuxiaodong@chinamobile.com) | Rel-10 | 47 | Patrick | eICIC_LTE-Core | RP-110543 |  |  |
| 6208 | 1999.2 | Perf. part: Enhanced Inter-Cell Interference Control (ICIC) for non-Carrier Aggregation (CA) based deployments of heterogeneous networks for LTE | 589d? | 2010-03-19 A | 2012-06-15 A | 100% | 2010-03-19 | 2012-06-15 | 589d? | finish no earlier than 2012-06-15 | R4 | 4712h | 4712h | eICIC_LTE-Perf | 24 | China Mobile | Xiaodong XU (xuxiaodong@chinamobile.com) | Rel-10 | 47 | Issam | eICIC_LTE-Perf | RP-120461 |  |  |
| 6209 | 1999.3 | Test part: Enhanced Inter-Cell Interference Control (ICIC) for non-Carrier Aggregation (CA) based deployments of heterogeneous networks for LTE | 600d? | 2012-03-05 A | 2014-06-13 A | 100% | 2012-03-05 | 2014-06-13 | 600d? | finish no earlier than 2014-06-13 | R5 | 4800h | 4800h | eICIC_LTE-UEConTest | 28 | Qualcomm | Anjali Mishra (ajha@qualcomm.com) | Rel-10 | 55 | Ingbert | eICIC_LTE-UEConTest | RP-140766 |  |  |
| 6210 | 2000 | **LTE TDD in 2600MHz for US** | 191d? | 2010-03-19 A | 2010-12-10 A | 100% | 2010-03-19 | 2010-12-10 | 191d? |  | R4; R2; R3; R5 | 11344h | 11344h | LTE_TDD_2600_US | 24 | Clearwire | michael.hart@clearwire.com | Rel-10 | 47 | Issam | LTE_TDD_2600_US |  |  |  |
| 6211 | 2000.1 | Core part: LTE TDD in 2600MHz for US | 129d? | 2010-03-19 A | 2010-09-15 A | 100% | 2010-03-19 | 2010-09-17 | 131d? | finish no earlier than 2010-09-17 | R4; R2; R3 | 3096h | 3096h | LTE_TDD_2600_US-Core | 24 | Clearwire | michael.hart@clearwire.com | Rel-10 | 47 | Issam | LTE_TDD_2600_US-Core | RP-100782 |  |  |
| 6212 | 2000.2 | Perf. part: LTE TDD in 2600MHz for US | 131d? | 2010-03-19 A | 2010-09-17 A | 100% | 2010-03-19 | 2010-09-17 | 131d? | finish no earlier than 2010-09-17 | R4 | 1048h | 1048h | LTE_TDD_2600_US-Perf | 24 | Clearwire | michael.hart@clearwire.com | Rel-10 | 47 | Issam | LTE_TDD_2600_US-Perf | RP-100783 |  |  |
| 6213 | 2000.3 | UE conformance test part: LTE TDD in 2600MHz for US | 136d? | 2010-06-04 A | 2010-12-10 A | 100% | 2010-06-04 | 2010-12-10 | 136d? | finish no earlier than 2010-12-10 | R5 | 1088h | 1088h | LTE_TDD_2600_US-UEConTest | 25 | Clearwire | michael.hart@clearwire.com | Rel-10 | 48 | Ingbert | LTE_TDD_2600_US-UEConTest | RP-101071 |  |  |
| 6214 | 2001 | **Adding 2 GHz band LTE FDD (Band 23) for Ancillary Terrestrial Component (ATC) of Mobile Satellite Service (MSS) in North America** | 454d? | 2010-03-19 A | 2011-12-09 A | 100% | 2010-03-19 | 2011-12-09 | 454d? |  | R2; R4; R5 | 19568h | 19568h | S_Band_LTE_ATC_MSS | 24 | DBSD | Mariam.Sorond@ico.com | Rel-10 | 47 | Yong-Jun | S_Band_LTE_ATC_MSS |  |  |  |
| 6215 | 2001.1 | Core part: Adding 2 GHz band LTE FDD (Band 23) for ATC of MSS in North America | 316d? | 2010-03-19 A | 2011-06-03 A | 100% | 2010-03-19 | 2011-06-03 | 316d? | finish no earlier than 2011-06-03 | R4; R2 | 5056h | 5056h | S_Band_LTE_ATC_MSS-Core | 24 | DBSD | Mariam.Sorond@ico.com | Rel-10 | 47 | Issam | S_Band_LTE_ATC_MSS-Core | RP-110545 |  |  |
| 6216 | 2001.2 | Perf. part: Adding 2 GHz band LTE FDD (Band 23) for ATC of MSS in North America | 316d? | 2010-03-19 A | 2011-06-03 A | 100% | 2010-03-19 | 2011-06-03 | 316d? | finish no earlier than 2011-06-03 | R4 | 2528h | 2528h | S_Band_LTE_ATC_MSS-Perf | 24 | DBSD | Mariam.Sorond@ico.com | Rel-10 | 47 | Issam | S_Band_LTE_ATC_MSS-Perf | RP-110546 |  |  |
| 6217 | 2001.3 | Test part: Adding 2 GHz band LTE FDD (Band 23) for ATC of MSS in North America | 137d? | 2011-06-07 A | 2011-12-09 A | 100% | 2011-06-07 | 2011-12-09 | 137d? | finish no earlier than 2011-12-09 | R5 | 1088h | 1088h | S_Band_LTE_ATC_MSS-UEConTest | 27 | DBSD | Mariam.Sorond@ico.com | Rel-10 | 52 | Ingbert | S_Band_LTE_ATC_MSS-UEConTest | RP-111444 |  |  |

Notes:
- 6193: - / Impacted TSs and TRs: LTE
- 6194: RP#52 completed. TR 36.817 v110 for Approval. RP#56 new TR 36.807 v200 for Approval / Impacted TSs and TRs: 36.101; 36.104; 36.133; 36.201; 36.211; 36.212; 36.213; 36.300; 36.306; 36.321; 36.331; new RAN4 (36.807; 36.817)
- 6195: RP#53 completed / Impacted TSs and TRs: 36.101; 36.104; 36.133; 36.141; 36.817
- 6196: RP#59 completed / Impacted TSs and TRs: 36.508; 36.521-1; 36.521-2; 36.521-3; 36.523-1; 36.523-2; 36.523-3
- 6197: RP#52 completed (open RAN4 Core & Perf parts moved to new Rel-11) / Impacted TSs and TRs: LTE
- 6198: RP#52 completed. Updated WID RP-101417=>RP-101911 (contains only Core part completed in Rel-10). Open RAN4 Core & Perf parts moved to new Rel-11 / Impacted TSs and TRs: 36.201; 36.211; 36.212; 36.213; 36.300; 36.321; 36.323; 36.331; New RAN1 36.216
- 6199: RP#52 stopped at 30% (no CRs so far) . Transferred completely to Rel-11 together with remaining core part / Impacted TSs and TRs: 36.133; New 36.117 (E-UTRA Relay conformance testing)
- 6200: SP#52 SP-110338 (S2-85/S2-112851) 23.401 Cat F CR#2128 Completion of Relay procedure overview / Impacted TSs and TRs: 23.401
- 6201: -
- 6202: SP#51 completed / Impacted TSs and TRs: 33.816
- 6203: SP#51 completed (impacting Stage 3 in CT and RAN) / Impacted TSs and TRs: 33.401 (CR#0437.0438); CT1 24.301; CT4 (29.272; 29.274); CT6 31.102; RAN2 (36.331; 36.323); RAN3 36.413
- 6204: CP#51 completed / Impacted TSs and TRs: 31.101; 31.102
- 6205: CP#51 completed / Impacted TSs and TRs: 23.003; 23.008; 29.303; 29.230; 29.272
- 6206: RP#56 completed / Impacted TSs and TRs: LTE
- 6207: RP#52 completed / Impacted TSs and TRs: 36.101; 36.133; 36.201; 36.211; 36.212; 36.213; 36.214; 36.300; 36.321; 36.331; 36.413; 36.423
- 6208: RP#56 completed / Impacted TSs and TRs: 36.101; 36.133
- 6209: RP#64 completed / Impacted TSs and TRs: 36.508; 36.521-1; 36.521-2; 36.521-3; 36.523-1; 36.523-2; 36.523-3
- 6210: RP#50 Testing completed. RP#49 Core+Perf completed / Impacted TSs and TRs: LTE
- 6211: RP#49 completed 1st Apr 15: CD:Fri 17/09/10->Wed 15/09/10 / Impacted TSs and TRs: 25.461; 25.466; 36.101; 36.104; 36.113; 36.124; 36.133; 36.141; 36.307; 36.331; 37.104; 37.113; 37.141; new 36.812
- 6212: RP#49 completed / Impacted TSs and TRs: 36.101; 36.104; 36.133; 36.141; 36.307; 37.104; 37.141; new 36.812
- 6213: RP#50 completed / Impacted TSs and TRs: 36.508; 36.521-1; 36.521-2; 36.521-3; 36.523-1; 36.523-2; 36.523-3
- 6214: RP#52 completed. Updated WID RP-101401=>RP-110775 (changed in Title "LTE" to "LTE FDD (Band 23)" / Impacted TSs and TRs: LTE
- 6215: RP#52 completed / Impacted TSs and TRs: 25.101; 25.104; 25.141; 25.461; 25.466; 36.101; 36.104; 36.113; 36.124; 36.133; 36.307; 37.104; 37.141; new 36.811
- 6216: RP#52 completed / Impacted TSs and TRs: 36.101; 36.104; 36.113; 36.124; 36.133; 36.141; 36.307; 36.811
- 6217: RP#54 completed / Impacted TSs and TRs: 36.508; 36.521-1; 36.521-2; 36.521-3; 36.523-1; 36.523-2; 36.523-3

| ID | WBS | Task | Duration | Start | Finish | Complete | Baseline start | Baseline finish | Baseline duration | Constraint | Resources | Work | Actual work | Acronym | PCG approved | WI rapporteur name | WI rapporteur e-mail | Release | TSG approved | MCC resp | Acronym_3GU_Export | Status Report | Special Focus Doc |
| --- | --- | --- | --- | --- | --- | --- | --- | --- | --- | --- | --- | --- | --- | --- | --- | --- | --- | --- | --- | --- | --- | --- | --- |
| 6218 | 2002 | **Adding L-Band (Band 24) LTE for Ancillary Terrestrial Component (ATC) of Mobile Satellite Service (MSS) in North America** | 463d? | 2009-12-11 A | 2011-09-16 A | 100% | 2009-12-11 | 2011-09-16 | 463d? |  | R4; R2; R5 | 18864h | 18864h | L_Band_LTE_ATC_MSS | 24 | LightSquared | Eric.Jacks@lightsquared.com, Maqbool.Aliani@lightsquared.com | Rel-10 | 47 | Issam | L_Band_LTE_ATC_MSS |  |  |
| 6219 | 2002.1 | Core part: Adding L-Band (Band 24) LTE for ATC of MSS in North America | 261d? | 2009-12-11 A | 2010-12-10 A | 100% | 2009-12-11 | 2010-12-10 | 261d? | finish no earlier than 2010-12-10 | R4; R2 | 4176h | 4176h | L_Band_LTE_ATC_MSS-Core | 24 | LightSquared | Eric.Jacks@lightsquared.com, Maqbool.Aliani@lightsquared.com | Rel-10 | 47 | Issam | L_Band_LTE_ATC_MSS-Core | RP-101117 |  |
| 6220 | 2002.2 | Perf. part: Adding L-Band (Band 24) LTE for ATC of MSS in North America | 316d? | 2010-03-19 A | 2011-06-03 A | 100% | 2010-03-19 | 2011-06-03 | 316d? | finish no earlier than 2011-06-03 | R4 | 2528h | 2528h | L_Band_LTE_ATC_MSS-Perf | 24 | LightSquared | Eric.Jacks@lightsquared.com, Maqbool.Aliani@lightsquared.com | Rel-10 | 47 | Issam | L_Band_LTE_ATC_MSS-Perf | RP-110548 |  |
| 6221 | 2002.3 | Test part: Adding L-Band (Band 24) LTE for ATC of MSS in North America | 131d? | 2011-03-18 A | 2011-09-16 A | 100% | 2011-03-18 | 2011-09-16 | 131d? | finish no earlier than 2011-09-16 | R5 | 1048h | 1048h | L_Band_LTE_ATC_MSS-UEConTest | 26 | LightSquared | masoud.olfat@lightsquared.com | Rel-10 | 51 | Ingbert | L_Band_LTE_ATC_MSS-UEConTest | RP-110980 |  |
| 6222 | 2003 | **LTE Self Optimizing Networks (SON) enhancements** | 316d? | 2010-03-19 A | 2011-06-03 A | 100% | 2010-03-19 | 2011-06-03 | 316d? |  | R3; R2; R4 | 15168h | 15168h | SONenh_LTE | 24 | Nokia Siemens Networks | krzysztof.kordybach@nsn.com | Rel-10 | 47 | Juha | SONenh_LTE |  | SON |
| 6223 | 2003.1 | Core part: LTE Self Optimizing Networks (SON) enhancements | 316d? | 2010-03-19 A | 2011-06-03 A | 100% | 2010-03-19 | 2011-06-03 | 316d? | finish no earlier than 2011-06-03 | R3; R2; R4 | 7584h | 7584h | SONenh_LTE-Core | 24 | Nokia Siemens Networks | krzysztof.kordybach@nsn.com | Rel-10 | 47 | Juha | SONenh_LTE-Core | RP-110547 | SON |
| 6224 | 2004 | **Further enhancements to MBMS for LTE** | 459d? | 2010-06-04 A | 2012-03-02 A | 100% | 2010-06-04 | 2012-03-02 | 459d? |  | R2; R3; R5 | 14840h | 14840h | MBMS_LTE_enh | 25 | Huawei | Ms Zhao Junhui (zhaojh@huawei.com) | Rel-10 | 48 | Yong-Jun | MBMS_LTE_enh |  |  |
| 6225 | 2004.1 | Core part: Further enhancements to MBMS for LTE | 206d? | 2010-06-04 A | 2011-03-18 A | 100% | 2010-06-04 | 2011-03-18 | 206d? | finish no earlier than 2011-03-18 | R2; R3 | 3296h | 3296h | MBMS_LTE_enh-Core | 25 | Huawei | Ms Zhao Junhui (zhaojh@huawei.com) | Rel-10 | 48 | Yong-Jun | MBMS_LTE_enh-Core | RP-110083 |  |
| 6226 | 2004.2 | Test part: Further enhancements to MBMS for LTE | 66d? | 2011-12-02 A | 2012-03-02 A | 100% | 2011-12-02 | 2012-03-02 | 66d? | finish no earlier than 2012-03-02 | R5 | 528h | 528h | MBMS_LTE_enh-UEConTest | 28 | Huawei | Zhang Xin (suzanna.zhang@huawei.com) | Rel-10 | 54 | Ingbert | MBMS_LTE_enh-UEConTest | RP-120049 |  |
| 6227 | 2005 | **UMTS/LTE 3500 MHz** | 1456d? | 2007-11-30 A | 2013-06-14 A | 100% | 2007-11-30 | 2013-06-14 | 1456d? |  | R4; R2; R3; R5 | 87360h | 87360h | RInImp8-UMTSLTE3500 | 21 | Ericsson | johan.skold@ericsson.com | Rel-10 | 38 | Issam | RInImp8-UMTSLTE3500 |  |  |
| 6228 | 2005.1 | Core part: UMTS/LTE 3500 MHz | 994d? | 2007-11-30 A | 2011-09-16 A | 100% | 2007-11-30 | 2011-09-16 | 994d? | finish no earlier than 2011-09-16 | R4; R2; R3 | 23856h | 23856h | RInImp8-UMTSLTE3500 | 21 | Ericsson | johan.skold@ericsson.com | Rel-10 | 38 | Issam | RInImp8-UMTSLTE3500 | RP-110987 |  |
| 6229 | 2005.2 | Conformance Test Aspects – LTE 3500 | 1189d? | 2008-12-05 A | 2013-06-14 A | 100% | 2008-12-05 | 2013-06-14 | 1189d? | finish no earlier than 2013-06-14 | R5 | 9512h | 9512h | LTE-UEConTest_LTE3500 | 22 | Ericsson | fredrik.sundstrom@ericsson.com | Rel-10 | 42 | Ingbert | LTE-UEConTest_LTE3500 | RP-130461 |  |
| 6230 | 2005.3 | Conformance Test Aspects – UMTS 3500 | 925d? | 2008-12-05 A | 2012-06-15 A | 100% | 2008-12-05 | 2012-06-15 | 925d? | finish no earlier than 2012-06-15 | R5 | 7400h | 7400h | RInImp-UEConTest_UMTS3500 | 22 | Ericsson | fredrik.sundstrom@ericsson.com | Rel-10 | 42 | Ingbert | RInImp-UEConTest_UMTS3500 | RP-120450 |  |
| 6231 | 2006 | **Minimization of Drive Tests for E-UTRAN and UTRAN** | 854d? | 2009-12-04 A | 2013-03-01 A | 100% | 2009-12-04 | 2013-03-01 | 854d? |  | R2; R4; R3; R5 | 39784h | 39784h | MDT_UMTSLTE | 24 | Nokia Siemens Networks | malgorzata.tomala@nsn.com | Rel-10 | 46 | Yong-Jun | MDT_UMTSLTE |  |  |
| 6232 | 2006.1 | Core part: Minimization of Drive Tests for E-UTRAN and UTRAN | 391d? | 2009-12-04 A | 2011-06-03 A | 100% | 2009-12-04 | 2011-06-03 | 391d? | finish no earlier than 2011-06-03 | R2; R4; R3 | 9384h | 9384h | MDT_UMTSLTE-Core | 24 | Nokia Siemens Networks | malgorzata.tomala@nsn.com | Rel-10 | 46 | Yong-Jun | MDT_UMTSLTE-Core | RP-110528 |  |
| 6233 | 2006.2 | Test part: Minimization of Drive Tests for E-UTRAN | 384d? | 2011-09-19 A | 2013-03-01 A | 100% | 2011-09-19 | 2013-03-01 | 384d? | finish no earlier than 2013-03-01 | R5 | 3072h | 3072h | MDT_UMTSLTE-UEConTest | 27 | Ericsson | leif.mattisson@ericsson.com | Rel-10 | 53 | Ingbert | MDT_UMTSLTE-UEConTest | RP-130036 |  |
| 6234 | 2007 | **HNB and HeNB Mobility Enhancements** | 718d? | 2010-03-19 A | 2012-12-07 A | 100% | 2010-03-19 | 2012-12-07 | 718d? |  | R3; R2; R5 | 23016h | 23016h | HNB_HENB_mob_enh | 24 | Alcatel-Lucent | Martin,Warner@alcatel-lucent.com | Rel-10 | 47 | Juha | HNB_HENB_mob_enh |  | HNB |
| 6235 | 2007.1 | Core part: HNB and HeNB Mobility Enhancements | 261d? | 2010-03-19 A | 2011-03-18 A | 100% | 2010-03-19 | 2011-03-18 | 261d? | start no earlier than 2010-03-19 | R3; R2 | 4176h | 4176h | HNB_HENB_mob_enh-Core | 24 | Alcatel-Lucent | Martin.Warner@alcatel-lucent.com | Rel-10 | 47 | Juha | HNB_HENB_mob_enh-Core | RP-110058 | HNB |
| 6236 | 2007.2 | Test part: HeNB Mobility Enhancements | 201d? | 2012-03-05 A | 2012-12-07 A | 100% | 2012-03-05 | 2012-12-07 | 201d? | finish no earlier than 2012-12-07 | R5 | 1608h | 1608h | HNB_HENB_mob_enh-UEConTest_LTE | 28 | Qualcomm | Anjali Mishra (ajha@qualcom.com) | Rel-10 | 55 | Ingbert | HNB_HENB_mob_enh-UEConTest_LTE | RP-121533 | HNB |
| 6237 | 2008 | **Expanded 1900 MHz Band for UTRA and LTE** | 596d? | 2010-06-04 A | 2012-09-07 A | 100% | 2010-06-04 | 2012-09-07 | 596d? |  | R4; R2; R5 | 25312h | 25312h | E1900 | 25 | Sprint | nick.j.baustert@sprint.com | Rel-10 | 48 | Issam | E1900 |  |  |
| 6238 | 2008.1 | Core part: Expanded 1900 MHz Band for UTRA and LTE | 261d? | 2010-06-04 A | 2011-06-03 A | 100% | 2010-06-04 | 2011-06-03 | 261d? | finish no earlier than 2011-06-03 | R4; R2 | 4176h | 4176h | E1900-Core | 25 | Sprint | nick.j.baustert@sprint.com | Rel-10 | 48 | Issam | E1900-Core | RP-110529 |  |
| 6239 | 2008.2 | Perf. part: Expanded 1900 MHz Band for UTRA and LTE | 261d? | 2010-06-04 A | 2011-06-03 A | 100% | 2010-06-04 | 2011-06-03 | 261d? | finish no earlier than 2011-06-03 | R4; R2 | 4176h | 4176h | E1900-Perf | 25 | Sprint | nick.j.baustert@sprint.com | Rel-10 | 48 | Issam | E1900-Perf | RP-110530 |  |
| 6240 | 2008.3 | Test part: Expanded 1900 MHz Band for UTRA and LTE | 333d? | 2011-06-07 A | 2012-09-07 A | 100% | 2011-06-07 | 2012-09-07 | 333d? | finish no earlier than 2012-09-07 | R5 | 2656h | 2656h | E1900-UEConTest | 27 | Sprint | nick.j.baustert@sprint.com | Rel-10 | 52 | Ingbert | E1900-UEConTest | RP-120957 |  |
| 6241 | 2009 | **Multi-Standard Radio Base Station RF requirements for non-contiguous spectrum deployments** | 389d? | 2010-06-04 A | 2011-11-25 A | 100% | 2010-06-04 | 2011-11-25 | 389d? |  | R4; G1 | 16160h | 16160h | MSR_NC | 25 | Ericsson | johan.skold@ericsson.com | Rel-10 | 48 | Issam | MSR_NC |  |  |
| 6242 | 2009.1 | Core part: Multi-Standard Radio BS RF requirements for non-contiguous spectrum deployments | 261d? | 2010-06-04 A | 2011-06-03 A | 100% | 2010-06-04 | 2011-06-03 | 261d? | finish no earlier than 2011-06-03 | R4 | 2088h | 2088h | MSR_NC-Core | 25 | Ericsson | johan.skold@ericsson.com | Rel-10 | 48 | Issam | MSR_NC-Core | RP-110531 |  |
| 6243 | 2009.2 | Perf. part: Multi-Standard Radio BS RF requirements for non-contiguous spectrum deployments | 336d? | 2010-06-04 A | 2011-09-16 A | 100% | 2010-06-04 | 2011-09-16 | 336d? | finish no earlier than 2011-09-16 | R4 | 2688h | 2688h | MSR_NC-Perf | 25 | Ericsson | johan.skold@ericsson.com | Rel-10 | 48 | Issam | MSR_NC-Perf | RP-110988 |  |

Notes:
- 6218: RP#53 completed / Impacted TSs and TRs: LTE
- 6219: RP#51 completed / Impacted TSs and TRs: 25.101; 25.104; 25.141; 25.461; 25.466; 34.124; 36.101; 36.104; 36.113; 36.124; 36.133; 36.307; 37.104; 37.141; new RAN4 36.813
- 6220: RP#52 completed / Impacted TSs and TRs: 34.121-1; 36.101; 36.104; 36.113; 36.124; 36.133; 36.141; 36.307; 36.521-1; 36.813
- 6221: RP#53 completed / Impacted TSs and TRs: 36.508; 36.521-1; 36.521-2; 36.521-3; 36.523-2
- 6222: RP#52 completed / Impacted TSs and TRs: LTE
- 6223: RP#52 completed (Stage 1,2,3) / Impacted TSs and TRs: 36.300; 36.331; 36.413; 36.423
- 6224: RP#51 completed. SA2 decided not to support MBR>GBR in Rel-10 MBMS. For SA2, MBR=GBR in Rel-10 MBMS. Hence RAN removed enabling statistical multiplexing gains for variable bit rate services in Objectives / Impacted TSs and TRs: LTE
- 6225: RP#51 completed / Impacted TSs and TRs: 25.446; 36.300; 36.321; 36.322; 36.323; 36.331; 36.440; 36.441; 36.442; 36.443; 36.444; 36.445
- 6226: RP#55 completed / Impacted TSs and TRs: 36.508; 36.523-1; 36.523-2; 36.523-3
- 6227: - / Impacted TSs and TRs: UTRA; LTE
- 6228: RP#53 completed. TR 37.801v200 for Approval / Impacted TSs and TRs: 25.101; 25.104; 25.113; 25.133; 25.141; 25.307; 25.307; 25.331; 25.461; 25.463; 34.124; 36.101; 36.104; 36.113; 36.141; 36.331; new 37.801
- 6229: RP#60 completed / Impacted TSs and TRs: 36.508; 36.521-1; 36.521-2; 36.521-3
- 6230: RP#56 completed / Impacted TSs and TRs: 34.108; 34.121-1; 34.121-2
- 6231: Triggered by UID_430021 TR 36.805 (Study on Minimization of drive-tests in NGN) / Impacted TSs and TRs: UTRA; LTE
- 6232: RP#52 completed / Impacted TSs and TRs: 25.133; 25.215; 25.304; 25.331; 25.423; 36.133; 36.214; 36.300; 36.304; 36.331; 36.413; 36.423; new 37.320 (Stage 2)
- 6233: RP#59 completed. Testing for LTE only / Impacted TSs and TRs: LTE 34.108; 34.109; 34.123-1; 34.123-2; 34.123-3; 36.508; 36.509; 36.523-1; 36.523-2; 36.523-3
- 6234: - / Impacted TSs and TRs: UTRA; LTE
- 6235: RP#51 completed / Impacted TSs and TRs: 25.413; 25.467; 25.469; 36.300; 36.413; 36.423; new 25.471
- 6236: RP#58 completed / Impacted TSs and TRs: 34.108; 34.123-1; 34.123-2; 34.123-3; 36.508; 36.523-1; 36.523-2; 36.523-3
- 6237: Expand UTRA and E-UTRA band 2 to include frequencies between 1910 1915 MHz and 1990-1995 MHz (US FCC allocation) / Impacted TSs and TRs: UTRA; LTE
- 6238: RP#52 completed / Impacted TSs and TRs: 25.101; 25.104; 25.113; 25.133; 25.141; 25.461; 25.466; 36.101; 36.104; 36.113; 36.124; 36.133; 36.141; 36.307; 36.331; new 36.818
- 6239: RP#52 completed / Impacted TSs and TRs: 25.101; 25.104; 25.113; 25.133; 25.141; 25.461; 25.466; 36.101; 36.104; 36.113; 36.124; 36.133; 36.141; 36.307; 36.331; new 36.818
- 6240: RP#57 completed / Impacted TSs and TRs: 34.108; 34.121-1; 34.121-2; 34.123-1; 34.123-2; 34.123-3; 36.508; 36.521-1; 36.521-2; 36.521-3; 36.523-1; 36.523-2; 36.523-3
- 6241: - / Impacted TSs and TRs: UTRA; LTE; GERAN
- 6242: RP#52 completed / Impacted TSs and TRs: 25.104; 36.104; 37.104; new 37.802
- 6243: RP#53 completed / Impacted TSs and TRs: 25.141; 36.141; 37.141; 37.802

| ID | WBS | Task | Type | Duration | Start | Finish | Complete | Baseline start | Baseline finish | Baseline duration | Constraint | Resources | Work | Actual work | Acronym | PCG approved | WI rapporteur name | WI rapporteur e-mail | Release | TSG approved | MCC resp | Acronym_3GU_Export | Impacted TSs and TRs | PCG stopped | TSG stopped | Status Report | Special Focus Doc |
| --- | --- | --- | --- | --- | --- | --- | --- | --- | --- | --- | --- | --- | --- | --- | --- | --- | --- | --- | --- | --- | --- | --- | --- | --- | --- | --- | --- |
| 6244 | 2009.3 | **GERAN part: Multi-Standard Radio BS RF requirements for non-contiguous spectrum deployments** |  | 324d? | 2010-09-03 A | 2011-11-25 A | 100% | 2010-09-03 | 2011-11-25 | 324d? |  | G1 | 5160h | 5160h | MSR_NC-GERAN | 25 | Ericsson | mats.y.samuelsson@ericsson.com | Rel-10 | 47 | Paolo | MSR_NC-GERAN |  |  |  |  |  |
| 6245 | 2009.3.1 | GERAN Core part: Multi-Standard Radio BS RF requirements for non-contiguous spectrum deployments |  | 261d? | 2010-09-03 A | 2011-09-02 A | 100% | 2010-09-03 | 2011-09-02 | 261d? | finish no earlier than 2011-09-02 | G1 | 2088h | 2088h | MSR_NC-GERAN | 25 | Ericsson | mats.y.samuelsson@ericsson.com | Rel-10 | 47 | Paolo |  | 45.005 |  |  |  |  |
| 6246 | 2009.3.2 | GERAN BS Test part: Multi-Standard Radio BS RF requirements for non-contiguous spectrum deployments |  | 62d? | 2011-09-02 A | 2011-11-25 A | 100% | 2011-09-02 | 2011-11-25 | 62d? | finish no earlier than 2011-11-25 | G1 | 496h | 496h | MSR_NC-GERAN | 28 | Ericsson | mats.y.samuelsson@ericsson.com | Rel-10 | 52 | Paolo |  | 51.021 |  |  |  |  |
| 6247 | 2010 | (Small) Technical Enhancements and Improvements for Rel-10 |  | 470d? | 2009-06-04 A | 2011-03-23 A | 100% | 2009-06-04 | 2011-03-23 | 470d? | finish no earlier than 2011-03-23 | SP; CP; RP; GP | 15040h | 15040h | TEI10 | 23 |  |  | Rel-10 | 44 |  | TEI10 |  |  |  |  |  |
| 6248 | 2011 | (IETF) (Small) Technical Enhancements and Improvements for Rel-10 (draft-atarius-dispatch-meid-urn) --> RFC8464 |  | 1244d? | 2009-06-04 A | 2014-12-04 A | 100% | 2009-06-04 | 2014-12-05 | 1242d? | finish no earlier than 2014-12-09 | C1-IETF | 9952h | 9952h | TEI10_IETF | 27 | Andrew Allen | Andrew Allen | Rel-10 | 52 | Frederic | TEI10_IETF | draft-atarius-dispatch-meid-urn |  |  |  |  |
| 6249 | 2012 | (IETF) (Small) Technical Enhancements and Improvements for Rel-10 (RFC6275) |  | 562d? | 2009-06-04 A | 2011-07-29 A | 100% | 2009-06-04 | 2011-07-29 | 562d? | finish no earlier than 2011-07-29 | C1-IETF | 4496h | 4496h | TEI10_IETF1 | 27 |  |  | Rel-10 | 53 | Frederic | TEI10_IETF1 | RFC 6275 (was draft-ietf-mext-rfc3775bis) |  |  |  |  |
| 6250 | 2013 | Test - (Small) Technical Enhancements and Improvements for Rel-10 |  | 271d? | 2011-12-01 A | 2012-12-07 A | 100% | 2011-12-01 | 2012-12-07 | 271d? | finish no earlier than 2012-12-07 | R5; G3new | 4336h | 4336h | TEI10_Test | 28 | n/a |  | Rel-10 | 54 | Ingbert | TEI10_Test |  |  |  |  |  |
| 6251 | 2014 | **Deleted - Registration in Densely-populated area (RED)** |  | 665d? | 2007-03-12 A | 2009-09-24 A | 100% | 2007-03-12 | 2009-09-24 | 665d? |  | S1 | 9544h | 9544h | RED | 18 | NTT DoCoMo | tanakai@nttdocomo.co.jp | Rel-10 | 35 | Alain | RED |  | PCG-24 | SP-46 |  |  |
| 6252 | 2014.1 | Deleted - Stage 1 for RED |  | 4d? | 2007-03-12 A | 2007-03-15 A | 100% | 2007-03-12 | 2007-03-15 | 4d? | start no earlier than 2007-03-12 | S1 | 32h | 32h | RED | 19 | NTT DoCoMo | takakurat@s1.nttdocomo.co.jp | Rel-10 | 37 | Alain |  | 22.101 CR#0207 | PCG-24 | SP-46 |  |  |
| 6253 | 2014.2 | Deleted - Stage 2 for RED |  | 524d? | 2007-09-25 A | 2009-09-24 A | 100% | 2007-09-25 | 2009-09-24 | 524d? | finish no earlier than 2009-09-24 | S2 | 4192h | 4192h | RED | 19 | NTT DoCoMo | tanakai@nttdocomo.co.jp | Rel-10 | 37 | Maurice |  | draft 23.880 withdrawn; 23.002; 23.060; 23.221; 23.236 | PCG-23 | SP-45 |  |  |
| 6254 | 2015 | **Deleted - Network Selection for non-3GPP Access** |  | 471d? | 2007-12-07 A | 2009-09-24 A | 100% | 2007-12-07 | 2009-09-24 | 471d? |  | S1; C6 | 15072h | 15072h | N3GtoNSP | 21 | Telefónica O2 | chris.friel@O2.com | Rel-10 | 38 | Alain | N3GtoNSP |  | PCG-23 | SP-45 |  |  |
| 6255 | 2015.1 | Deleted - Stage 1 for N3GtoNSP |  | 471d? | 2007-12-07 A | 2009-09-24 A | 100% | 2007-12-07 | 2009-09-24 | 471d? | finish no earlier than 2009-12-10 | S1 | 3768h | 3768h | N3GtoNSP | 21 | Telefónica O2 | chris.friel@O2.com | Rel-10 | 38 | Alain |  | 22.011 | PCG-23 | SP-45 |  |  |
| 6256 | 2015.2 | Deleted - CT6 issues for N3GtoNSP |  | 471d? | 2007-12-07 A | 2009-09-24 A | 100% | 2007-12-07 | 2009-09-24 | 471d? | finish no earlier than 2009-12-04 | C6 | 3768h | 3768h | N3GtoNSP | 21 | Telefónica O2 | chris.friel@O2.com | Rel-10 | 38 | Xavier |  | 36.300 | PCG-23 | CP-45 |  |  |
| 6257 | 2016 | **Deleted - GTP-based S8 chaining** |  | 337d? | 2008-12-11 A | 2010-03-25 A | 100% | 2008-12-11 | 2010-03-25 | 337d? |  | S2 | 5392h | 5392h | GTPchaining | 22 | Huawei | Haining Wang (wanghaining@huawei.com) | Rel-10 | 42 | Maurice | GTPchaining |  | PCG-24 | SP-47 |  |  |
| 6258 | 2016.1 | Deleted - Stage 2 for GTPchaining |  | 337d? | 2008-12-11 A | 2010-03-25 A | 100% | 2008-12-11 | 2010-03-25 | 337d? | finish no earlier than 2010-03-25 | S2 | 2696h | 2696h | GTPchaining | 22 | Huawei | Haining Wang (wanghaining@huawei.com) | Rel-10 | 42 | Maurice |  | 23.402 | PCG-24 | SP-47 |  |  |
| 6259 | 2017 | Deleted - UTRAN 2 ms TTI uplink range improvement |  | 272d? | 2009-03-06 A | 2010-03-19 A | 100% | 2009-03-06 | 2010-03-19 | 272d? | finish no earlier than 2010-03-19 | R1; R2; R3; R4 | 8704h | 8704h | RANimp-2mTTI_ULimp | 22 | Nokia Siemens Networks | Karri Ranta-aho (karri.ranta-aho@nsn.com) | Rel-10 | 43 | Patrick | RANimp-2mTTI_ULimp | 25.133; 25.212; 25.214; 25.321; 25.331 | PCG-24 | RP-47 | RP-100040 |  |
| 6260 | 2018 | Deleted - Enhanced Home NodeB / eNodeB continuation of Rel-9 |  | 337d? | 2008-12-11 A | 2010-03-25 A | 100% | 2008-12-11 | 2010-03-25 | 337d? |  | S2 | 2696h | 2696h | eEHNB | 23 | Alcatel-Lucent | Nicolas Drevon | Rel-10 | 44 | Maurice | eEHNB |  | PCG-24 | SP-47 |  | HNB |
| 6261 | 2019 | **Deleted - Fixed Wireless Customer-Premises Equipment (CPE) RF Requirements** |  | 391d? | 2009-12-04 A | 2011-06-03 A | 100% | 2009-12-04 | 2011-06-03 | 391d? |  | R4; R5 | 12512h | 12512h | FW_CPE_RF | 24 | Verizon Wireless | zheng.zhao@verizonwireless.com | Rel-10 | 46 | Issam | FW_CPE_RF | LTE | PCG-27 | RP-52 |  |  |
| 6262 | 2019.1 | Deleted - Core part: Fixed Wireless Customer-Premises Equipment (CPE) RF Requirements |  | 391d? | 2009-12-04 A | 2011-06-03 A | 100% | 2009-12-04 | 2011-06-03 | 391d? | finish no earlier than 2011-06-03 | R4 | 3128h | 3128h | FW_CPE_RF-Core | 24 | Verizon Wireless | zheng.zhao@verizonwireless.com | Rel-10 | 46 | Issam | FW_CPE_RF-Core | 36.101 | PCG-27 | RP-52 | RP-110539 |  |
| 6263 | 2019.2 | Deleted - Test part: Fixed Wireless Customer-Premises Equipment (CPE) RF Requirements |  | 391d? | 2009-12-04 A | 2011-06-03 A | 100% | 2009-12-04 | 2011-06-03 | 391d? | finish no earlier than 2011-06-03 | R5 | 3128h | 3128h | FW_CPE_RF-UEConTest | 24 | Verizon Wireless | zheng.zhao@verizonwireless.com | Rel-10 | 46 | Ingbert | FW_CPE_RF-UEConTest | 36.521-1 | PCG-27 | RP-52 | RP-110504 |  |
| 6264 | 2020 | **Deleted - Latency reductions for LTE** |  | 266d? | 2009-12-04 A | 2010-12-10 A | 100% | 2009-12-04 | 2010-12-10 | 266d? |  | R2; R1 | 8512h | 8512h | LTE_LATRED | 24 | Ericsson | henrik.enbuske@ericsson.com | Rel-10 | 46 | Yong-Jun | LTE_LATRED | LTE | PCG-26 | RP-50 |  |  |
| 6265 | 2020.1 | Deleted - Core part: Latency reductions for LTE |  | 266d? | 2009-12-04 A | 2010-12-10 A | 100% | 2009-12-04 | 2010-12-10 | 266d? | finish no earlier than 2010-12-10 | R2; R1 | 4256h | 4256h | LTE_LATRED-Core | 24 | Ericsson | henrik.enbuske@ericsson.com | Rel-10 | 46 | Yong-Jun | LTE_LATRED-Core | 36.213; 36.300; 36.306; 36.321; 36.331 | PCG-26 | RP-50 | RP-101112 |  |
| 6266 | 2021 | **Deleted - Enhanced Interference Management for Home NodeBs** |  | 131d? | 2010-03-19 A | 2010-09-17 A | 100% | 2010-03-19 | 2010-09-17 | 131d? |  | R3 | 2096h | 2096h | HNB_IM | 24 | Qualcomm | Andrei Radulescu (aradules@qualcomm.com) | Rel-10 | 47 | Juha | HNB_IM | UTRA | PCG-25 | RP-49 | RP-100754 | HNB |
| 6267 | 2021.1 | Deleted - Core part: Enhanced Interference Management for Home NodeBs |  | 131d? | 2010-03-19 A | 2010-09-17 A | 100% | 2010-03-19 | 2010-09-17 | 131d? | finish no earlier than 2010-09-17 | R3 | 1048h | 1048h | HNB_IM-Core | 24 | Qualcomm | Andrei Radulescu (aradules@qualcomm.com) | Rel-10 | 47 | Juha | HNB_IM-Core | 25.413; 25.467; 25.469 | PCG-25 | RP-49 | RP-100754 | HNB |
| 6268 | 2022 | Release 10 Studies | milestone | 0d? | 2009-03-12 A | 2009-03-12 A | 100% | 2009-03-12 | 2011-03-23 | 531d? | finish no earlier than 2011-03-23 | CP; GP; RP; SP |  |  |  |  |  |  | Rel-10 |  |  |  |  |  |  |  |  |

Notes:
- 6244: -
- 6245: GP#51 completed. GP#47 approved WID
- 6246: GP#52 completed
- 6247: -
- 6248: Not completed internet-draft, waiting for draft-montemurro to complete; 26/6/19: 75%->100; 23/4/20: 100%->100
- 6249: SP#53/IETF#81: RFC 6275 completed
- 6250: -
- 6251: SP#35 Stage 1 completed. SP#45 Stage 2 work stopped. SP#46 work stopped/abandoned
- 6252: SP#35 completed. SP#46 work stopped/abandoned
- 6253: SP#45 Stage 2 work stopped
- 6254: SP#45 work stopped/abandoned
- 6255: SP#45 work stopped/abandoned
- 6256: SP#45 work stopped/abandoned
- 6257: SP#47 work stopped (depending on ongoing related CT4 work). Stage 1 in UID_320022 Rel-8 Requirements for evolution of the 3GPP system architecture (AIPN-SAE): 22.278, 22.011, 22.246
- 6258: SP#47 work stopped
- 6259: RP#47 work stopped/abandoned (no CR approved). Cell sets the TTI (Transmission Time Interval) to 2 ms
- 6260: SP#47 deleted (SA2 work moved under SA1 UID_450053). SP#44 Umbrella Feature created to host WIs moved out of Rel-9 (SA2 UID_420034 on IMS aspects of Architecture for Home NodeB)
- 6261: RP#52 work stopped (lack of contributions). Add new power classES in CP-150E-UTRAN UL to allow CPE type applications to be operated at higher max output power
- 6262: RP#52 work stopped at 55% (lack of contributions)
- 6263: RP#52 work stopped (lack of contributions)
- 6264: RP#50 work stopped (RP-101266)
- 6265: RP#50 work stopped (RP-101266)
- 6266: RP#49 stopped (no further standardization needed). Ensure that Enhanced Interference Management methods identified in Rel-9 for HNBs do not fail in deployments with a large penetration of CSG-aware UEs
- 6267: RP#49 stopped (no further standardization needed)
- 6268: -

| ID | WBS | Task | Type | Duration | Start | Finish | Complete | Baseline start | Baseline finish | Baseline duration | Constraint | Resources | Work | Actual work | Acronym | PCG approved | Impacted TSs and TRs | WI rapporteur name | Release | TSG approved | MCC resp | Acronym_3GU_Export | Status Report | PCG stopped | TSG stopped |
| --- | --- | --- | --- | --- | --- | --- | --- | --- | --- | --- | --- | --- | --- | --- | --- | --- | --- | --- | --- | --- | --- | --- | --- | --- | --- |
| 6269 | 2023 | **Study on enhanced voice service requirements for the Evolved Packet System (EPS)** |  | 670d? | 2007-09-03 A | 2010-03-25 A | 100% | 2007-09-03 | 2010-03-25 | 670d? |  | S1; S4 | 18744h | 18744h | FS_EV_EPS | 19 | 22.813 | France Telecom | Rel-10 | 37 | Alain | FS_EV_EPS |  |  |  |
| 6270 | 2023.1 | Use cases definition and service and system requirements |  | 334d? | 2007-09-03 A | 2008-12-11 A | 100% | 2007-09-03 | 2008-12-11 | 334d? | finish no earlier than 2008-12-11 | S1 | 2672h | 2672h | FS_EV_EPS-S1 | 19 | 22.813 | France Telecom | Rel-10 | 37 | Alain | FS_EV_EPS-S1 |  |  |  |
| 6271 | 2023.2 | Codec specific part of FS_EV_EPS |  | 669d? | 2007-09-03 A | 2010-03-25 A | 100% | 2007-09-03 | 2010-03-25 | 669d? | finish no earlier than 2010-03-25 | S4 | 5352h | 5352h | FS_EV_EPS-S4 | 19 | 22.813 | Ericsson | Rel-10 | 37 | Paolo | FS_EV_EPS-S4 |  |  |  |
| 6272 | 2024 | Study on advanced requirements for IP interconnect |  | 528d? | 2007-12-04 A | 2009-12-10 A | 100% | 2007-12-04 | 2009-12-10 | 528d? | finish no earlier than 2009-12-10 | S1 | 4224h | 4224h | FS_IPXS | 21 | 22.893 | Telefónica O2 | Rel-10 | 38 | Alain | FS_IPXS |  |  |  |
| 6273 | 2025 | Study on Personal Broadcast Service |  | 397d? | 2008-09-18 A | 2010-03-25 A | 100% | 2008-09-18 | 2010-03-25 | 397d? | finish no earlier than 2010-03-25 | S1 | 3168h | 3168h | FS_PBS | 21 | 22.947 | ETRI | Rel-10 | 41 | Alain | FS_PBS |  |  |  |
| 6274 | 2026 | Study on LCS support in SAE for non-3GPP accesses |  | 397d? | 2008-09-18 A | 2010-03-25 A | 100% | 2008-09-18 | 2010-03-25 | 397d? | finish no earlier than 2010-03-25 | S1 | 3168h | 3168h | FS_LCS_n3GPP | 21 | 22.814 | SK Telecom | Rel-10 | 41 | Alain | FS_LCS_n3GPP |  |  |  |
| 6275 | 2027 | Study on Haptic Services |  | 272d? | 2009-03-12 A | 2010-03-25 A | 100% | 2009-03-12 | 2010-03-25 | 272d? | finish no earlier than 2010-03-25 | S1 | 2168h | 2168h | FS_Haptics | 22 | 22.987 | SK Telecom | Rel-10 | 43 | Alain | FS_Haptics |  |  |  |
| 6276 | 2028 | Study on System enhancements for the use of IMS services in Local BreakOut and Optimal Routing of Media |  | 575d? | 2007-10-01 A | 2009-12-10 A | 100% | 2007-10-01 | 2009-12-10 | 575d? | finish no earlier than 2009-12-10 | S2 | 4600h | 4600h | FS_IMS_LBO_ORM | 19 | 23.894 | Telecom Italia, BT | Rel-10 | 37 | Maurice | FS_IMS_LBO_ORM |  |  |  |
| 6277 | 2029 | Study on Intra Domain Connection of RAN Nodes to Multiple CN Nodes |  | 533d? | 2008-03-12 A | 2010-03-25 A | 100% | 2008-03-12 | 2010-03-25 | 533d? | finish no earlier than 2010-03-25 | S2 | 4264h | 4264h | FS_IDC | 21 | 23.924 (was 23.823) | China Mobile | Rel-10 | 39 | Maurice | FS_IDC |  |  |  |
| 6278 | 2030 | Study on Single Radio Voice Call Continuity enhancements |  | 341d? | 2009-06-04 A | 2010-09-23 A | 100% | 2009-06-04 | 2010-09-23 | 341d? | finish no earlier than 2010-09-23 | S2 | 2728h | 2728h | FS_eSRVCC | 23 | 23.856 | China Mobile | Rel-10 | 44 | Maurice | FS_eSRVCC |  |  |  |
| 6279 | 2031 | Study on Single Radio Video Call Continuity for 3G-CS |  | 131d? | 2010-03-25 A | 2010-09-23 A | 100% | 2010-03-25 | 2010-09-23 | 131d? | finish no earlier than 2010-09-23 | S2 | 1048h | 1048h | FS_vSRVCC | 24 | 23.886 | Samsung | Rel-10 | 47 | Maurice | FS_vSRVCC |  |  |  |
| 6280 | 2032 | Study on S2b Mobility based on GTP |  | 56d? | 2010-03-25 A | 2010-06-10 A | 100% | 2010-03-25 | 2010-06-10 | 56d? | finish no earlier than 2010-06-07 | S2 | 448h | 448h | FS_SMOG | 24 | 23.834 | Alcatel-Lucent | Rel-10 | 47 | Maurice | FS_SMOG |  |  |  |
| 6281 | 2033 | Study on Surround Sound codec extension for PSS and MBMS |  | 530d? | 2009-03-12 A | 2011-03-23 A | 100% | 2009-03-12 | 2011-03-23 | 530d? | finish no earlier than 2011-03-23 | S4 | 4240h | 4240h | FS_SS_PSS_MBMS | 22 | 26.950 | Fraunhofer Gesellschaft | Rel-10 | 43 | Paolo | FS_SS_PSS_MBMS |  |  |  |
| 6282 | 2034 | Study on Improved Video Coding Support |  | 205d? | 2010-06-10 A | 2011-03-23 A | 100% | 2010-06-10 | 2011-03-23 | 205d? | finish no earlier than 2011-03-23 | S4 | 1640h | 1640h | FS_IVCS | 25 | 26.904 | Nokia, ETRI | Rel-10 | 48 | Paolo | FS_IVCS |  |  |  |
| 6283 | 2035 | Study on Rc Reference Point Functionalities and Message Flows |  | 397d? | 2008-09-18 A | 2010-03-25 A | 100% | 2008-09-18 | 2010-03-25 | 397d? | finish no earlier than 2010-03-23 | S5 | 3170.08h | 3170.08h | FS_OAM_Rc | 21 | 32.825 | Huawei | Rel-10 | 41 | Mirko | FS_OAM_Rc |  |  |  |
| 6284 | 2036 | Study on Telecommunication Management; Energy Savings Management |  | 271d? | 2009-03-12 A | 2010-03-25 A | 100% | 2009-03-12 | 2010-03-25 | 271d? | finish no earlier than 2010-03-25 | S5 | 2168h | 2168h | FS_OAM_ESM | 22 | 32.826 | Orange, Vodafone | Rel-10 | 43 | Mirko | FS_OAM_ESM |  |  |  |
| 6285 | 2037 | Study on Integration of Device Management Information with Itf-N |  | 211d? | 2009-06-04 A | 2010-03-25 A | 100% | 2009-06-04 | 2010-03-25 | 211d? | finish no earlier than 2010-03-25 | S5 | 1688h | 1688h | FS_IDMI_Itf-N | 23 | 32.827 | Motorola | Rel-10 | 44 | Mirko | FS_IDMI_Itf-N |  |  |  |
| 6286 | 2038 | Study on Alignment of 3GPP Generic NRM IRP and TMF Shared Information Data (SID) model |  | 335d? | 2009-12-10 A | 2011-03-23 A | 100% | 2009-12-10 | 2011-03-23 | 335d? | finish no earlier than 2011-03-23 | S5 | 2680h | 2680h | FS_3GNRM_TMFSID | 24 | 32.828 | Nokia Siemens Networks | Rel-10 | 46 | Mirko | FS_3GNRM_TMFSID |  |  |  |
| 6287 | 2039 | Study on Harmonization of 3GPP Alarm IRP and TMF Interface Program (TIP) Fault Management |  | 335d? | 2009-12-10 A | 2011-03-23 A | 100% | 2009-12-10 | 2011-03-23 | 335d? | finish no earlier than 2011-03-23 | S5 | 2680h | 2680h | FS_3G_TMF_FM | 24 | 32.829 | Nokia Siemens Networks, Alcatel-Lucent | Rel-10 | 46 | Mirko | FS_3G_TMF_FM |  |  |  |
| 6288 | 2040 | Study on Alarm Correlation and Alarm Root Cause Analysis |  | 205d? | 2010-06-10 A | 2011-03-23 A | 100% | 2010-06-10 | 2011-03-23 | 205d? | finish no earlier than 2011-03-23 | S5 | 1640h | 1640h | FS_AC_ARCA | 25 | 32.832 | Ericsson | Rel-10 | 48 | Mirko | FS_AC_ARCA |  |  |  |
| 6289 | 2041 | Study on Alignment of 3GPP PM IRP and TMF Interface Program (TIP) PM |  | 205d? | 2010-06-10 A | 2011-03-23 A | 100% | 2010-06-10 | 2011-03-23 | 205d? | finish no earlier than 2011-03-23 | S5 | 1640h | 1640h | FS_3G_TMF_PM | 25 | 32.831 | Alcatel-Lucent | Rel-10 | 48 | Mirko | FS_3G_TMF_PM |  |  |  |
| 6290 | 2042 | Study on Policy and Charging Rules Function (PCRF) failure and restoration |  | 261d? | 2009-08-18 A | 2010-09-17 A | 100% | 2009-08-18 | 2010-09-17 | 261d? | finish no earlier than 2010-09-17 | C3 | 2088h | 2088h | FS_PCRF-FR | 23 | 29.816 | NEC | Rel-10 | 45 | Adrian | FS_PCRF-FR |  |  |  |
| 6291 | 2043 | Study on User Data Convergence (UDC) evolution |  | 206d? | 2010-06-04 A | 2011-03-18 A | 100% | 2010-06-04 | 2011-03-18 | 206d? | finish no earlier than 2011-03-18 | C4 | 1648h | 1648h | FS_UDCe | 25 | 23.845 | Alcatel-Lucent | Rel-10 | 48 | Kimmo | FS_UDCe |  |  |  |
| 6292 | 2044 | Study on UICC access to IMS |  | 206d? | 2010-06-04 A | 2011-03-18 A | 100% | 2010-06-04 | 2011-03-18 | 206d? | finish no earlier than 2011-03-18 | C6 | 1648h | 1648h | FS_IMS-UICC | 25 | 31.828 | Gemalto | Rel-10 | 48 | Xavier | FS_IMS-UICC |  |  |  |
| 6293 | 2045 | Study on Uplink Tx Diversity for HSPA |  | 208.4d? | 2009-08-18 A | 2010-06-04 A | 100% | 2009-08-18 | 2010-06-04 | 208.4d? | finish no earlier than 2010-06-04 | R4 | 1667.2h | 1667.2h | FS_UL-TxDiv-HSPA | 23 | UTRA 25.863 | Qualcomm | Rel-10 | 45 | Issam | FS_UL-TxDiv-HSPA | RP-100499 |  |  |
| 6294 | 2046 | Study on Solutions for Energy Saving within UTRA Node B |  | 206d? | 2009-12-04 A | 2010-09-17 A | 100% | 2009-12-04 | 2010-09-17 | 206d? | finish no earlier than 2010-09-17 | R1; R3 | 3296h | 3296h | FS_Energy_UMTS | 24 | UTRA 25.927 | Vodafone | Rel-10 | 46 | Patrick | FS_Energy_UMTS | RP-100796 |  |  |
| 6295 | 2047 | Study on Potential solutions for energy saving for E-UTRAN |  | 348.75d? | 2010-02-02 A | 2011-06-03 A | 100% | 2010-02-02 | 2011-06-03 | 348.75d? | finish no earlier than 2011-06-03 | R3; R2 | 5580h | 5580h | FS_Energy_LTE | 24 | LTE 36.927 | China Mobile | Rel-10 | 47 | Juha | FS_Energy_LTE | RP-110597 |  |  |
| 6296 | 2048 | Study on Improvements of distributed antenna for 1.28Mcps TDD |  | 200.55d? | 2010-03-05 A | 2010-12-10 A | 100% | 2010-03-05 | 2010-12-10 | 200.55d? | finish no earlier than 2010-12-10 | R1; R2; R3 | 4813.2h | 4813.2h | FS_distr_ant_LCR_TDD | 24 | UTRA 25.865 | ZTE | Rel-10 | 47 | Patrick | FS_distr_ant_LCR_TDD | RP-101287 |  |  |
| 6297 | 2049 | Deleted - Study on Unauthenticated PS Emergency Calls |  | 471d? | 2008-06-05 A | 2010-03-25 A | 100% | 2008-06-05 | 2010-03-25 | 471d? | finish no earlier than 2010-03-25 | S1 | 3768h | 3768h | FS_UAPSEC | 21 | 22.984 | Nokia Siemens Networks | Rel-10 | 40 | Alain | FS_UAPSEC |  | PCG-24 | SP-47 |
| 6298 | 2050 | Deleted - Study on enhancements to IMS border functions for IMS Interconnection of services |  | 586d? | 2008-09-18 A | 2010-12-15 A | 100% | 2008-09-18 | 2010-12-15 | 586d? | finish no earlier than 2010-12-15 | S2 | 4688h | 4688h | FS_eIMS_IBCF | 21 | 23.848 | Starent Networks | Rel-10 | 41 | Maurice | FS_eIMS_IBCF |  | PCG-26 | SP-50 |
| 6299 | 2051 | Deleted - Study on EPC Charging enhancement |  | 211d? | 2009-06-04 A | 2010-03-25 A | 100% | 2009-06-04 | 2010-03-25 | 211d? | finish no earlier than 2010-03-25 | S5 | 1688h | 1688h | FS_EPCcharg | 23 |  | Nokia Siemens Networks | Rel-10 | 44 | Mirko | FS_EPCcharg |  | PCG-24 | SP-47 |
| 6300 | 2052 | Deleted - Study on Interworking Proxy between GTP based and PMIP based interfaces |  | 186d? | 2009-09-18 A | 2010-06-04 A | 100% | 2009-09-18 | 2010-06-04 | 186d? | finish no earlier than 2010-06-04 | C4 | 1488h | 1488h | FS_GTP-MIP-IW | 23 | 29.875 | NTT DoCoMo | Rel-10 | 45 | Kimmo | FS_GTP-MIP-IW |  | PCG-25 | CP-48 |
| 6301 | 2053 | --- RELEASE 9 --- | milestone | 0d? | 2000-01-01 A | 2000-01-01 A | 100% | 2000-01-01 | 2000-01-01 | 0d? |  | CP; GP; RP; SP |  |  |  |  |  |  | Rel-9 |  |  |  |  |  |  |

Notes:
- 6269: SP#47 completed. TR 22.813-100 for Approval. Spin-off Feature UID_470030 Codec for Enhanced Voice Services / WI rapporteur e-mail: philippe.lottin@orange.com
- 6270: SP#47 completed. TR 22.813-100 for Approval / WI rapporteur e-mail: philippe.lottin@orange.com
- 6271: SP#47 completed. TR 22.813-100 for Approval / WI rapporteur e-mail: stefan.bruhn@ericson.com
- 6272: SP#46 completed. Linked to Rel-8 Feature UID_380060 IP Interconnection of Services (IPinterc). Spin-off Feature Rel-11 UID_470051 Advanced IP Interconnection of Services / WI rapporteur e-mail: chris.friel@O2.com
- 6273: SP#47 completed / WI rapporteur e-mail: Jaihyung Cho
- 6274: SP#47 completed / WI rapporteur e-mail: jinhan.song@sktelecom.com
- 6275: SP#47 completed. Covers Mobile/Fixed/Cordless/etc terminals. Haptic (human-machine tactile communication) extend service offering & richness of user experience beyond current visual & auditory senses / WI rapporteur e-mail: jinhan.song@sktelecom.com
- 6276: SP#46 completed. Spin-off Feature UID_460028 Optimal Media Routeing (OMR). Linked to Study on Multimedia Session Continuity UID_350051, Study on Centralized IMS Service Control UID_330012, IMS inter-operator service interconnection interface UID_360011 / WI rapporteur e-mail: mario.madella@telecomitalia.it, victor.kueh@bt.com
- 6277: SP#47 completed. Concluded no further normative work expected. Linked to 23.236 / WI rapporteur e-mail: LIU HONG (liuhongyfw@chinamobile.com)
- 6278: SP#49 completed (Conclusion: select the SIP anchoring based solution for normative work CR (TEI10) introducing and completing stage-2). Analyzed performance of Rel-8 SRVCC solution from E-UTRAN/HSPA to UTRAN/GERAN / WI rapporteur e-mail: Hou zhiqiang (houzhiqiang@chinamobile.com), Jiang Yi (jiangyi@chinamobile.com)
- 6279: SP#49 completed. TR 23.886v100 for Approval. Related to Rel-8 UID_350030 Single Radio Voice Call Continuity for 3GPP (SAES-SRVCC). Study how to provide Video Call seamless service continuity for 3G/LTE terminal user / WI rapporteur e-mail: Haris Zisimopoulos (haris.z@samsung.com)
- 6280: SP#48 completed. Triggered by Rel-8 UID_350027 SAE for support for non-3GPP accesses. Nature of relationship: S2b one of the interfaces defined for non-3GPP accesses support in EPS. Stage 1 in Rel-8 UID_320022 (AIPN-SAE) 22.278,22.101 / WI rapporteur e-mail: bruno.landais@alcatel-lucent.com
- 6281: SP#51 completed. Extend Rel-8 UID_34043 (Extending PSS and MBMS User Services for optimized Mobile TV) / WI rapporteur e-mail: jan.plogsties@iis.franhofer.de
- 6282: SP#51 completed. Extends Rel-9 Improved Video Support for PSS and MBMS (UID_430039) / WI rapporteur e-mail: imed.bouazizi@nokia.com, jaihyung@etri.re.kr
- 6283: SP#47 completed / WI rapporteur e-mail: shan.mingjun@huawei.com
- 6284: SP#47 completed. Study result might impact Feature UID_420011 Self Organising Networks (SON) / WI rapporteur e-mail: Jean-Michel Cornilly (Orange)
- 6285: SP#47 completed / WI rapporteur e-mail: Yizhi Yao (yzyao@motorola.com)
- 6286: SP#51 completed / WI rapporteur e-mail: olaf.pollakowski@nsn.com
- 6287: SP#51 completed / WI rapporteur e-mail: olaf.pollakowski@nsn.com, Padma.Sudarsan@alcatel-lucent.com
- 6288: SP#51 completed / WI rapporteur e-mail: edwin.tse@ericsson.com
- 6289: SP#51 completed / WI rapporteur e-mail: Padma.Sudarsan@alcatel-lucent.com
- 6290: CP#49 completed / WI rapporteur e-mail: gottfried.punz@nw.neclab.eu
- 6291: CP#51 completed. Study UDC evolution from FeaturES in CP-150Rel-9 UID_400034 and Rel-10 UID_480011 UDC Data Model / WI rapporteur e-mail: jean-jacques.trottin@alcatel-lucent.com
- 6292: CP#51 completed / WI rapporteur e-mail: Denis.Lheriteau@gemalto.com
- 6293: RP#48 completed / WI rapporteur e-mail: Heechoon Lee (heechoon@qualcomm.com)
- 6294: RP#49 completed. Based on ETSI EE TS 102 706. / WI rapporteur e-mail: Prakash.bhat@vodafone.com
- 6295: RP#52 completed / WI rapporteur e-mail: Yang Ning (yangning@chinamobile.com)
- 6296: RP#50 completed. TR 25.865 v101 for Approval / WI rapporteur e-mail: huang.he4@zte.com.cn
- 6297: SP#47 work stopped/abandoned / WI rapporteur e-mail: Juergen.Merkel@nsn.com
- 6298: SP#50 work stopped. Additional work may be addressed as part of the Rel-11 Feature UID_470051 Advanced IP Interconnection of Services (IPXS) / WI rapporteur e-mail: Rajat Ghai (rghai@starentnetworks.com)
- 6299: SP#47 work stopped. Issue covered by Rel-10 UID_460039 Charging for LIPA_SIPTO and UID_4700xy Charging for IFOM / WI rapporteur e-mail: Gerald.Goermer@nsn.com
- 6300: CP#48 work stopped/abandoned / WI rapporteur e-mail: takaaki.matsuura.sp@s1.nttdocomo.com
- 6301: -

| ID | WBS | Task | Duration | Start | Finish | Complete | Baseline start | Baseline finish | Baseline duration | Constraint | Resources | Work | Actual work | Acronym | PCG approved | WI rapporteur name | WI rapporteur e-mail | Release | TSG approved | MCC resp | Special Focus Doc | Acronym_3GU_Export | Status Report |
| --- | --- | --- | --- | --- | --- | --- | --- | --- | --- | --- | --- | --- | --- | --- | --- | --- | --- | --- | --- | --- | --- | --- | --- |
| 6302 | 2054 | **Enhanced Home NodeB / eNodeB** | 921d? | 2008-06-05 A | 2011-12-09 A | 100% | 2008-06-05 | 2011-12-09 | 921d? |  | S1; S2; S3; S5; C1; C6; R2; R3; R4; R5; GP | 113136h | 113136h | EHNB | 21 | T-Mobile | michael.kurz@t-mobile.at | Rel-9 | 40 | Alain | HNB | EHNB |  |
| 6303 | 2054.1 | Stage 1 for EHNB | 261d? | 2008-06-05 A | 2009-06-04 A | 100% | 2008-06-05 | 2009-06-04 | 261d? | finish no earlier than 2009-06-04 | S1 | 2088h | 2088h | EHNB | 21 | T-Mobile | michael.kurz@t-mobile.at | Rel-9 | 40 | Alain | HNB |  |  |
| 6304 | 2054.2 | Architecture aspects of EHNB | 266d? | 2008-09-18 A | 2009-09-24 A | 100% | 2008-09-18 | 2009-09-24 | 266d? | finish no earlier than 2009-09-22 | S2 | 2128h | 2128h | EHNB | 21 | T-Mobile | sebastian.speicher@telekom.de | Rel-9 | 41 | Maurice | HNB |  |  |
| 6305 | 2054.3 | Security aspects of Enhanced Home NodeB / eNodeB | 262d? | 2008-12-11 A | 2009-12-10 A | 100% | 2008-12-11 | 2009-12-10 | 262d? | finish no earlier than 2009-12-10 | S3 | 2096h | 2096h | EHNB-Sec | 22 | Huawei | Marcus Wong (mwong@huawei.com) | Rel-9 | 42 | Mirko | HNB | EHNB-Sec |  |
| 6306 | 2054.4 | CT1 aspects - Support of Home NB and Home eNB enhancements | 321d? | 2009-09-18 A | 2010-12-10 A | 100% | 2009-09-18 | 2010-12-10 | 321d? | finish no earlier than 2010-12-10 | C1 | 2568h | 2568h | EHNB-CT1 | 23 | Qualcomm | Ramachandran Subramanian (rsubrama@qualcomm.com) | Rel-9 | 45 | Frederic | HNB | EHNB-CT1 |  |
| 6307 | 2054.5 | CT6 aspects - Support of Home NB and Home eNB enhancements | 131d? | 2009-09-18 A | 2010-03-19 A | 100% | 2009-09-18 | 2010-03-19 | 131d? | finish no earlier than 2010-03-19 | C6 | 1048h | 1048h | EHNB-CT6 | 23 | Qualcomm | Ramachandran Subramanian (rsubrama@qualcomm.com) | Rel-9 | 45 | Xavier | HNB | EHNB-CT6 |  |
| 6308 | 2054.6 | 3G HNB Gateway and LTE HeNB Gateway OAM&P | 336d? | 2008-12-11 A | 2010-03-25 A | 100% | 2008-12-11 | 2010-03-25 | 336d? | finish no earlier than 2010-03-25 | S5 | 2688h | 2688h | HNB-OAM_GW | 22 | China Mobile | GangChen (chengang@chinamobile.com) | Rel-9 | 42 | Mirko | HNB | HNB-OAM_GW |  |
| 6309 | 2054.7 | 3G HNB and LTE HeNB OAM&P Type 1 Interface | 272d? | 2009-03-12 A | 2010-03-25 A | 100% | 2009-03-12 | 2010-03-25 | 272d? | finish no earlier than 2010-03-25 | S5 | 2168h | 2168h | HNB_eHNB-OAM_Type1 | 22 | Huawei | Zou Lan (zlan@huawei.com) | Rel-9 | 43 | Mirko | HNB | HNB_eHNB-OAM_Type1 |  |
| 6310 | 2054.8 | 3G HNB and LTE HeNB OAM&P Type 2 Interface | 225d? | 2009-05-15 A | 2010-03-25 A | 100% | 2009-05-15 | 2010-03-25 | 225d? | finish no earlier than 2010-03-25 | S5 | 1800h | 1800h | HNB_eHNB-OAM_Type2 | 23 | Ericsson | edwin.tse@ericsson.com | Rel-9 | 44 | Mirko | HNB | HNB_eHNB-OAM_Type2 |  |
| 6311 | 2054.9 | LTE FDD Home eNodeB RF Requirements | 336d? | 2008-12-05 A | 2010-03-19 A | 100% | 2008-12-05 | 2010-03-19 | 336d? | finish no earlier than 2010-03-19 | R4 | 2688h | 2688h | HeNB-RF_FDD | 22 | Motorola | Ying Cai (yingcai@motorola.com) | Rel-9 | 42 | Issam | HNB | HeNB-RF_FDD | RP-100035 |
| 6312 | 2054.10 | LTE TDD Home eNodeB RF Requirements | 271d? | 2009-03-06 A | 2010-03-19 A | 100% | 2009-03-06 | 2010-03-19 | 271d? | finish no earlier than 2010-03-19 | R4 | 2168h | 2168h | HeNB-RF_TDD | 22 | China Mobile | Nan Li (linan@chinamobile.com) | Rel-9 | 43 | Issam | HNB | HeNB-RF_TDD | RP-100036 |
| 6313 | 2054.11 | Home NB and Home eNB enhancements - RAN3 aspects | 197d? | 2009-03-06 A | 2009-12-04 A | 100% | 2009-03-06 | 2009-12-04 | 197d? | finish no earlier than 2009-12-04 | R3 | 1576h | 1576h | EHNB-RAN3 | 22 | Alcatel-Lucent | Martin Warner (mw15@alcatel-lucent.com) | Rel-9 | 43 | Juha | HNB | EHNB-RAN3 | RP-091050 |
| 6314 | 2054.12 | Home NB and Home eNB enhancements - RAN2 aspects | 271d? | 2009-03-06 A | 2010-03-19 A | 100% | 2009-03-06 | 2010-03-19 | 271d? | finish no earlier than 2010-03-19 | R2 | 2168h | 2168h | EHNB-RAN2 | 22 | Huawei | Yang Xudong (yangxudong@huawei.com) | Rel-9 | 43 | Yong-Jun | HNB | EHNB-RAN2 | RP-100037 |
| 6315 | 2054.13 | Conformance Test Aspects – Home NB enhancements for FDD | 322d? | 2010-09-17 A | 2011-12-09 A | 100% | 2010-09-17 | 2011-12-09 | 322d? | finish no earlier than 2011-12-09 | R5 | 2568h | 2568h | EHNB-UTRA_FDD_UEConTest | 25 | Huawei | trica_li@huawei.com | Rel-9 | 49 | Ingbert | HNB | EHNB-UTRA_FDD_UEConTest | RP-111679 |
| 6316 | 2054.14 | Conformance Test Aspects – Home eNB enhancements | 201d? | 2010-12-10 A | 2011-09-16 A | 100% | 2010-12-10 | 2011-09-16 | 201d? | finish no earlier than 2011-09-16 | R5 | 1608h | 1608h | EHNB-LTE_UEConTest | 26 | Qualcomm | Mrs Lena Chaponniere (lchaponn@qualcomm.com) | Rel-9 | 50 | Ingbert | HNB | EHNB-LTE_UEConTest | RP-110972 |
| 6317 | 2054.15 | Home NB and Home eNB enhancements - GERAN aspects | 341d? | 2009-05-18 A | 2010-09-03 A | 100% | 2009-05-18 | 2010-09-03 | 341d? | finish no earlier than 2010-09-03 | GP | 2728h | 2728h | EHNB-GERAN | 23 | Nokia Siemens Networks | leonardo.provvedi@roke.co.uk | Rel-9 | 42 | Paolo | HNB | EHNB-GERAN |  |
| 6318 | 2055 | **Value-Added Services for Short Message Service** | 586d? | 2007-09-10 A | 2009-12-04 A | 100% | 2007-09-10 | 2009-12-04 | 586d? |  | S1; C4; C1 | 20264h | 20264h | VAS4SMS | 19 | China Mobile | Wu Bin (wubin@chinamobile.com) | Rel-9 | 37 | Alain |  | VAS4SMS |  |
| 6319 | 2055.1 | Stage 1 for VAS4SMS | 133d? | 2007-09-10 A | 2008-03-12 A | 100% | 2007-09-10 | 2008-03-12 | 133d? | finish no earlier than 2008-03-21 | S1 | 1064h | 1064h | VAS4SMS | 19 | China Mobile | Wu Bin (wubin@chinamobile.com) | Rel-9 | 37 | Alain |  |  |  |
| 6320 | 2055.2 | CT4 aspects of VAS4SMS Interface and Signalling Flow | 322d? | 2008-09-12 A | 2009-12-04 A | 100% | 2008-09-12 | 2009-12-04 | 322d? | finish no earlier than 2009-12-04 | C4 | 2568h | 2568h | VAS4SMS | 21 | China Mobile | Wu Bin (wubin@chinamobile.com) | Rel-9 | 41 | Kimmo |  |  |  |
| 6321 | 2055.3 | CT1 aspects of VAS4SMS Interface and Signalling Flow | 321d? | 2008-09-09 A | 2009-12-04 A | 100% | 2008-09-09 | 2009-12-04 | 321d? | finish no earlier than 2009-12-04 | C1 | 2568h | 2568h | VAS4SMS | 21 | China Mobile | Wu Bin (wubin@chinamobile.com) | Rel-9 | 41 | Frederic |  |  |  |
| 6322 | 2056 | **Definition of End-User Identity** | 334d? | 2007-09-03 A | 2008-12-11 A | 100% | 2007-09-03 | 2008-12-11 | 334d? |  | S1 | 5344h | 5344h | EUI | 19 | Nokia Siemens Networks | Juergen.Merkel@nsn.com | Rel-9 | 37 | Alain |  | EUI |  |
| 6323 | 2056.1 | Stage 1 for Definition of End-User Identity | 334d? | 2007-09-03 A | 2008-12-11 A | 100% | 2007-09-03 | 2008-12-11 | 334d? | finish no earlier than 2008-12-11 | S1 | 2672h | 2672h | EUI | 21 | Nokia Siemens Networks | Juergen.Merkel@nsn.com | Rel-9 | 38 | Alain |  |  |  |
| 6324 | 2057 | **Customized Ringing Signal** | 522d? | 2007-12-06 A | 2009-12-03 A | 100% | 2007-12-06 | 2009-12-03 | 522d? |  | S1; C1 | 11296h | 11296h | CRS | 21 | SK Telecom, China Mobile | Donghee Shim (SK Telecom), Jianping Zheng (China Mobile) | Rel-9 | 38 | Alain |  | CRS |  |
| 6325 | 2057.1 | Stage 1 for Customized Ringing Signal | 266d? | 2007-12-06 A | 2008-12-11 A | 100% | 2007-12-06 | 2008-12-11 | 266d? | finish no earlier than 2008-12-11 | S1 | 2128h | 2128h | CRS | 21 | SK Telecom, China Mobile | Donghee Shim (SK Telecom), Jianping Zheng (China Mobile) | Rel-9 | 38 | Alain |  |  |  |
| 6326 | 2057.2 | Stage 3 for IMS Customized Ringing Signal (CRS) Service | 136d? | 2009-05-29 A | 2009-12-03 A | 100% | 2009-05-29 | 2009-12-03 | 136d? | finish no earlier than 2010-06-04 | C1 | 816h | 816h | CRS | 23 | China Mobile | wangzhao | Rel-9 | 44 | Frederic |  |  |  |

Notes:
- 6302: RP#54 Testing completed / Impacted TSs and TRs: UTRA; LTE
- 6303: CP#49 the SA1-reqs are moving. CT1 will align when the work in SA1 is clear. (was SP#44 completed.) / Impacted TSs and TRs: 22.220; 22.011
- 6304: SP#45 completed / Impacted TSs and TRs: 23.401; 23.402; 23.060; New 23.830
- 6305: SP#46 completed / Impacted TSs and TRs: New 33.320
- 6306: CP#50 completed (Roaming aspects for manual CSG selection, Support of temporary users and CSG membership changes, Support of user controlled and operator controlled lists) / Impacted TSs and TRs: 23.122; 24.008; 24.285; 24.301
- 6307: CP#47 completed. Storing of CSG related data items on the USIM / Impacted TSs and TRs: 31.102
- 6308: SP#47 completed / Impacted TSs and TRs: 32.632; 32.633; 32.635; New (32.771; 32.772; 32.773; 32.775; 32.781; 32.782; 32.783; 32.785)
- 6309: SP#47 completed / Impacted TSs and TRs: 32.581; 32.582; 32.583; 32.584; New (32.591; 32.592; 32.593; 32.594)
- 6310: SP#47 completed / Impacted TSs and TRs: New (32.571; 32.572)
- 6311: RP#47 completed / Impacted TSs and TRs: 36.104; 36.141; New 36.921
- 6312: RP#47 completed / Impacted TSs and TRs: 36.104; 36.141; 36.300; 36.331; 36.413; New 36.922
- 6313: RP#46 completed (based on high priority items specified in RP-090995) / Impacted TSs and TRs: 25.413; 25.467; 25.467; 25.468; 25.469; 25.469; 36.401; 36.413; New 25.444
- 6314: RP#47 completed / Impacted TSs and TRs: 25.304; 25.331; 25.367; 36.300; 36.304; 36.331
- 6315: UTRA. RP#54 completed. Testing for UID_430026 Support of Home NB and Home eNB enhancements RAN2 aspects (25.304, 25.331, 25.367) / Impacted TSs and TRs: 34.108; 34.121-1; 34.121-2; 34.123-1; 34.123-2; 34.123-3
- 6316: RP#53 completed / Impacted TSs and TRs: 36.508; 36.523-1; 36.523-2; 36.523-3
- 6317: GP#47 completed. GP#42 WID approved / Impacted TSs and TRs: 43.055; 43.129; 44.018; 44.060; 45.008; 48.008; 48.018
- 6318: CP#46 completed
- 6319: SP#39 completed. SP#43 Feature moved to Rel-9 / Impacted TSs and TRs: new 22.142
- 6320: CP#46 completed / Impacted TSs and TRs: new 23.142
- 6321: CP#46 completed / Impacted TSs and TRs: 23.040
- 6322: SP#42 closed. Stage 1 work closed at 5% completion due to lack of input (added only the EUI definition in 21.905)
- 6323: SP#42 closed. Stage 1 work closed at 5% completion due to lack of input (added only the EUI definition in 21.905) / Impacted TSs and TRs: 21.905
- 6324: CP#48 completed
- 6325: SP#42 completed. / Impacted TSs and TRs: 22.173; new 22.183
- 6326: CP#48 completed / Impacted TSs and TRs: 24.173; new 24.183

| ID | WBS | Task | Type | Duration | Start | Finish | Complete | Baseline start | Baseline finish | Baseline duration | Constraint | Resources | Work | Actual work | Acronym | PCG approved | Impacted TSs and TRs | WI rapporteur name | Release | TSG approved | MCC resp | Special Focus Doc | Acronym_3GU_Export | Status Report |
| --- | --- | --- | --- | --- | --- | --- | --- | --- | --- | --- | --- | --- | --- | --- | --- | --- | --- | --- | --- | --- | --- | --- | --- | --- |
| 6327 | 2058 | **Public Warning System** |  | 1315d? | 2007-12-06 A | 2012-12-07 A | 100% | 2007-12-06 | 2012-12-07 | 1315d? |  | S1; C1; C4; R2; R3; R5 | 73920h | 73920h | PWS | 21 | LTE | T-Mobile | Rel-9 | 38 | Alain | Public Safety (I-A) | PWS |  |
| 6328 | 2058.1 | Stage 1 for Public Warning System |  | 266d? | 2007-12-06 A | 2008-12-11 A | 100% | 2007-12-06 | 2008-12-11 | 266d? | finish no earlier than 2008-12-11 | S1 | 2128h | 2128h | PWS | 21 | 22.268 | T-Mobile | Rel-9 | 38 | Alain | Public Safety (I-A) |  |  |
| 6329 | 2058.2 | **Stage 3 for Public Warning System** |  | 137d? | 2009-05-29 A | 2009-12-04 A | 100% | 2009-05-29 | 2009-12-04 | 137d? |  | C1; C4 | 4368h | 4368h | PWS-St3 | 23 |  | Qualcomm | Rel-9 | 44 | Frederic | Public Safety (I-A) | PWS-St3 |  |
| 6330 | 2058.2.1 | CT1 aspects of Stage 3 for Public Warning System |  | 137d? | 2009-05-29 A | 2009-12-04 A | 100% | 2009-05-29 | 2009-12-04 | 137d? | finish no earlier than 2009-12-04 | C1 | 1088h | 1088h | PWS-St3 | 23 | 23.041 | Qualcomm | Rel-9 | 44 | Frederic | Public Safety (I-A) |  |  |
| 6331 | 2058.2.2 | CT4 aspects of Stage 3 for Public Warning System |  | 136d? | 2009-05-30 A | 2009-12-04 A | 100% | 2009-05-30 | 2009-12-04 | 136d? | finish no earlier than 2009-12-04 | C4 | 1088h | 1088h | PWS-St3 | 23 | 29.168 | Qualcomm | Rel-9 | 44 | Kimmo | Public Safety (I-A) |  |  |
| 6332 | 2058.3 | Public Warning System (PWS) – RAN aspects |  | 136d? | 2009-05-30 A | 2009-12-04 A | 100% | 2009-05-30 | 2009-12-04 | 136d? | finish no earlier than 2009-12-04 | R2; R3 | 2176h | 2176h | PWS-RAN | 23 | LTE 36.300; 36.302; 36.331; 36.413 | AT&T | Rel-9 | 44 | Yong-Jun | Public Safety (I-A) | PWS-RAN | RP-091052 |
| 6333 | 2058.4 | Conformance Test Aspects – Public Warning System (PWS) – RAN aspects for LTE |  | 267d? | 2011-12-02 A | 2012-12-07 A | 100% | 2011-12-02 | 2012-12-07 | 267d? | finish no earlier than 2012-12-07 | R5 | 2128h | 2128h | PWS-RAN_UEConTest | 28 | 36.508; 36.523-1; 36.523-2; 36.523-3 | Qualcomm | Rel-9 | 54 | Ingbert | Public Safety (I-A) | PWS-RAN_UEConTest | RP-121525 |
| 6334 | 2059 | **Support of Personal Area Networks and Enhancements to Personal Network Management** |  | 523d? | 2008-06-05 A | 2010-06-04 A | 100% | 2008-06-05 | 2010-06-04 | 523d? |  | S1; C1 | 12544h | 12544h | PAN_EPNM | 21 |  | Vodafone | Rel-9 | 40 | Alain |  | PAN_EPNM |  |
| 6335 | 2059.1 | Stage 1 for Support of Personal Area Networks and Enhancements to Personal Network Management | milestone | 0d? | 2008-06-05 A | 2008-06-05 A | 100% | 2008-06-05 | 2008-06-05 | 0d? | finish no earlier than 2008-06-05 | S1 |  |  | PAN_EPNM | 21 | 22.259 | Vodafone | Rel-9 | 40 | Alain |  |  |  |
| 6336 | 2059.2 | Stage 2 for Support of Personal Area Networks and Enhancements to Personal Network Management |  | 196d? | 2009-03-06 A | 2009-12-04 A | 100% | 2009-03-06 | 2009-12-04 | 196d? | finish no earlier than 2009-12-04 | C1 | 1568h | 1568h | PAN_EPNM | 22 | 23.259 | Huawei | Rel-9 | 43 | Frederic |  |  |  |
| 6337 | 2059.3 | Stage 3 for Support of Personal Area Networks and Enhancements to Personal Network Management |  | 326d? | 2009-03-09 A | 2010-06-04 A | 100% | 2009-03-09 | 2010-06-04 | 326d? | finish no earlier than 2010-06-04 | C1 | 2608h | 2608h | PAN_EPNM | 22 | 24.259 | Huawei | Rel-9 | 43 | Frederic |  |  |  |
| 6338 | 2060 | **Multi-Media Telephony Service enhancements** |  | 472d? | 2008-06-05 A | 2010-03-25 A | 100% | 2008-06-05 | 2010-03-25 | 472d? |  | S1; S5; C1 | 17840h | 17840h | eMMTel | 21 |  | France Telecom | Rel-9 | 40 | Alain |  | eMMTel |  |
| 6339 | 2060.1 | Stage 1 for eMMTel |  | 136d? | 2008-06-05 A | 2008-12-11 A | 100% | 2008-06-05 | 2008-12-11 | 136d? | start no earlier than 2008-06-05 | S1 | 1088h | 1088h | eMMTel | 21 | 22.173 | France Telecom | Rel-9 | 40 | Alain |  |  |  |
| 6340 | 2060.2 | Multimedia Telephony (MMTel) Service and Supplementary Services - Online Charging and completion for Offline Charging (all supplementary services) |  | 272d? | 2009-03-12 A | 2010-03-25 A | 100% | 2009-03-12 | 2010-03-25 | 272d? | finish no earlier than 2010-03-25 | S5 | 2168h | 2168h | eMMTel-SS-CH | 22 | 32.275; 32.298; 32.299 | Alcatel-Lucent | Rel-9 | 43 | Mirko |  | eMMTel-SS-CH |  |
| 6341 | 2060.3 | Support of Real-time Transfer of Tariff Information (RTTI) in IMS charging |  | 271d? | 2009-03-12 A | 2010-03-25 A | 100% | 2009-03-12 | 2010-03-25 | 271d? | finish no earlier than 2010-03-25 | S5 | 2168h | 2168h | IMSTSS-RTTI-CH | 22 | 32.240; 32.280; 32.298; 32.299 | Orange | Rel-9 | 43 | Mirko |  | IMSTSS-RTTI-CH |  |
| 6342 | 2060.4 | Stage 3 - Enhancements for Completion of Communications Supplementary service |  | 136d? | 2009-05-30 A | 2009-12-04 A | 100% | 2009-05-30 | 2009-12-04 | 136d? | finish no earlier than 2009-12-04 | C1 | 1088h | 1088h | eMMTel-CC | 23 | 24.642 | France Telecom | Rel-9 | 44 | Frederic |  | eMMTel-CC |  |
| 6343 | 2061 | **User Data Convergence (UDC)** |  | 527d? | 2008-06-05 A | 2010-06-10 A | 100% | 2008-06-05 | 2010-06-10 | 527d? |  | S1; S5; C4 | 25056h | 25056h | UDC | 21 |  | Nokia Siemens Networks | Rel-9 | 40 | Alain |  | UDC |  |
| 6344 | 2061.1 | Stage 1 for User Data Convergence (UDC) |  | 136d? | 2008-06-05 A | 2008-12-11 A | 100% | 2008-06-05 | 2008-12-11 | 136d? | start no earlier than 2008-06-05 | S1 | 1088h | 1088h | UDC | 21 | 22.101; new 22.985 | Nokia Siemens Networks | Rel-9 | 40 | Alain |  |  |  |
| 6345 | 2061.2 | **Stage 2/3 for User Data Convergence (UDC) Technical Realization** |  | 272d? | 2009-03-06 A | 2010-03-19 A | 100% | 2009-03-06 | 2010-03-19 | 272d? |  | C4 | 5376h | 5376h | UDC-CN | 22 |  | Ericsson | Rel-9 | 43 | Kimmo |  | UDC-CN |  |
| 6346 | 2061.2.1 | User Data Convergence (UDC) Technical Realization (Stage 2) |  | 271d? | 2009-03-06 A | 2010-03-19 A | 100% | 2009-03-06 | 2010-03-19 | 271d? | finish no earlier than 2010-03-19 | C4 | 2168h | 2168h | UDC-CN | 22 | new 23.335 | Ericsson | Rel-9 | 43 | Kimmo |  |  |  |
| 6347 | 2061.2.2 | User Data Convergence (UDC) Protocol Description |  | 130d? | 2009-09-18 A | 2010-03-19 A | 100% | 2009-09-18 | 2010-03-19 | 130d? | finish no earlier than 2010-03-19 | C4 | 1040h | 1040h | UDC-CN | 23 | new 29.335 | China Mobile, Ericsson | Rel-9 | 45 | Kimmo |  |  |  |
| 6348 | 2061.3 | **User Data Convergence (UDC) Modelling and Management** |  | 266d? | 2009-06-04 A | 2010-06-10 A | 100% | 2009-06-04 | 2010-06-10 | 266d? |  | S5 | 5944h | 5944h | UDC-MMAN | 23 |  | T-Mobile, China Mobile, Ericsson | Rel-9 | 44 | Mirko |  | UDC-MMAN |  |
| 6349 | 2061.3.1 | UDC – Framework for Model Handling and Management |  | 266d? | 2009-06-04 A | 2010-06-10 A | 100% | 2009-06-04 | 2010-06-10 | 266d? | finish no earlier than 2010-06-10 | S5 | 2128h | 2128h | UDC-MMAN-MFRM | 23 | 32.172; new 32.181 | T-Mobile | Rel-9 | 44 | Mirko |  | UDC-MMAN-MFRM |  |
| 6350 | 2061.3.2 | UDC – Common Baseline Information Model |  | 211d? | 2009-06-04 A | 2010-03-25 A | 100% | 2009-06-04 | 2010-03-25 | 211d? | finish no earlier than 2010-03-25 | S5 | 1688h | 1688h | UDC-MMAN-CBIM | 23 | 32.172; new 32.182 | China Mobile, Ericsson | Rel-9 | 44 | Mirko |  | UDC-MMAN-CBIM |  |

Notes:
- 6327: TSG#46 completed. Larger scope than Rel-8 Feature UID_370051 (ETWS). Triggered by TR 22.968 Study UID_320025 (FS_PWS) / WI rapporteur e-mail: Mark.Younge@t-mobile.com
- 6328: SP#42 completed / WI rapporteur e-mail: Mark.Younge@t-mobile.com
- 6329: RP#46 completed / WI rapporteur e-mail: Ramachandran Subramanian (rsubrama@qualcomm.com)
- 6330: CP#46 completed / WI rapporteur e-mail: Ramachandran Subramanian (rsubrama@qualcomm.com)
- 6331: CP#46 completed / WI rapporteur e-mail: Ramachandran Subramanian (rsubrama@qualcomm.com)
- 6332: RP#46 completed / WI rapporteur e-mail: don.zelmer@att.com
- 6333: RP#58 completed / WI rapporteur e-mail: Shubhang Vora (svora@qualcomm.com)
- 6334: CP#48 completed / WI rapporteur e-mail: armin.toepfer@vodafone.com
- 6335: SP#40 completed / WI rapporteur e-mail: armin.toepfer@vodafone.com
- 6336: CP#46 completed / WI rapporteur e-mail: Lili Yang (kadyyang@huawei.com)
- 6337: CP#48 completed / WI rapporteur e-mail: Lili Yang (kadyyang@huawei.com)
- 6338: SP#47 completed / WI rapporteur e-mail: philippe.lottin@orange.com
- 6339: SP#42 completed / WI rapporteur e-mail: philippe.lottin@orange.com
- 6340: SP#47 completed / WI rapporteur e-mail: maryse.gardella@alcatel-lucent.com
- 6341: SP#47 completed. Linked to SA5 Rel-8 UID_380042 AoC support in IMS Charging (IMSTSS) / WI rapporteur e-mail: Jean-Luc Garcia (jl.garcia@orange-ftgroup.com)
- 6342: CP#46 completed / WI rapporteur e-mail: Youssef.chadli@orange-ftgroup.com
- 6343: SP#48 completed. Triggered by Rel-8 SA5 Study of Common Profile Storage Framework of User Data for network services and management (UID_320006) TR 32.808 / WI rapporteur e-mail: juergen.merkel@nsn.com
- 6344: SP#42 completed / WI rapporteur e-mail: juergen.merkel@nsn.com
- 6345: - / WI rapporteur e-mail: emiliano.merino@ericsson.com
- 6346: CP#47 completed / WI rapporteur e-mail: emiliano.merino@ericsson.com
- 6347: CP#47 completed / WI rapporteur e-mail: Lan Si Zhong (lansizhong@chinamobile.com), emiliano.merino@ericsson.com
- 6348: SP#48 completed / WI rapporteur e-mail: istvan.aba@t-mobile.at, lansizhong@chinamobile.com, miguel.a.garcia@ericsson.com
- 6349: SP#48 completed / WI rapporteur e-mail: istvan.aba@t-mobile.at
- 6350: SP#47 completed / WI rapporteur e-mail: Lan Si Zhong, Miguel Garcia

| ID | WBS | Task | Duration | Start | Finish | Complete | Baseline start | Baseline finish | Baseline duration | Constraint | Resources | Work | Actual work | Acronym | PCG approved | WI rapporteur name | WI rapporteur e-mail | Release | TSG approved | MCC resp | Acronym_3GU_Export | Status Report | Special Focus Doc |
| --- | --- | --- | --- | --- | --- | --- | --- | --- | --- | --- | --- | --- | --- | --- | --- | --- | --- | --- | --- | --- | --- | --- | --- |
| 6351 | 2062 | **IMS Services Centralization and Continuity** | 393d? | 2008-09-18 A | 2010-03-19 A | 100% | 2008-09-18 | 2010-03-19 | 393d? |  | S1; S2; C1 | 30992h | 30992h | IMS_SCC | 21 | NEC | joerg.swetina@neclab.eu | Rel-9 | 41 | Alain | IMS_SCC |  |  |
| 6352 | 2062.1 | Stage 1 - Inter-Device Transfer – Requirements | 61d? | 2008-09-18 A | 2008-12-11 A | 100% | 2008-09-18 | 2008-12-11 | 61d? | finish no earlier than 2009-06-18 | S1 | 488h | 488h | IMS_SCC-IDT | 21 | NEC | joerg.swetina@neclab.eu | Rel-9 | 41 | Alain | IMS_SCC-IDT |  |  |
| 6353 | 2062.2 | **Stage 2/3 for IMS Service Continuity Enhancements: Service, Policy and Interactions** | 393d? | 2008-09-18 A | 2010-03-19 A | 100% | 2008-09-18 | 2010-03-19 | 393d? |  | S2; C1 | 9456h | 9456h | IMS_SCC-SPI | 21 | Huawei | HengLiang Zhang (hl_zhang@huawei.com) | Rel-9 | 41 | Maurice | IMS_SCC-SPI |  |  |
| 6354 | 2062.2.1 | Stage 2 for IMS Service Continuity Enhancements: Service, Policy and Interactions | 186d? | 2008-09-18 A | 2009-06-04 A | 100% | 2008-09-18 | 2009-06-04 | 186d? | finish no earlier than 2009-06-04 | S2 | 1488h | 1488h | IMS_SCC-SPI | 21 | Huawei | HengLiang Zhang (hl_zhang@huawei.com) | Rel-9 | 41 | Maurice |  |  |  |
| 6355 | 2062.2.2 | Stage 3 for IMS Service Continuity Enhancements: Service, Policy, Interactions and Inter UE Transfer | 212d? | 2009-05-29 A | 2010-03-19 A | 100% | 2009-05-29 | 2010-03-19 | 212d? | finish no earlier than 2010-03-19 | C1 | 1696h | 1696h | IMS_SCC-SPI | 23 | Qualcomm | Roozbeh Atarius (ratarius@qualcomm.com) | Rel-9 | 44 | Frederic |  |  |  |
| 6356 | 2062.3 | **Stage 2/3 for IMS Centralized Services** | 393d? | 2008-09-18 A | 2010-03-19 A | 100% | 2008-09-18 | 2010-03-19 | 393d? |  | S2; C1 | 9448h | 9448h | IMS_SCC-ICS | 21 | Alcatel-Lucent | andy.bennett@alcatel-lucent.com | Rel-9 | 41 | Maurice | IMS_SCC-ICS |  |  |
| 6357 | 2062.3.1 | Stage 2 for IMS Centralized Services | 186d? | 2008-09-18 A | 2009-06-04 A | 100% | 2008-09-18 | 2009-06-04 | 186d? | finish no earlier than 2009-06-04 | S2 | 1488h | 1488h | IMS_SCC-ICS | 21 | Alcatel-Lucent | andy.bennett@alcatel-lucent.com | Rel-9 | 41 | Maurice |  |  |  |
| 6358 | 2062.3.2 | Stage 3 for Enhancements to IMS Centralized Services | 212d? | 2009-05-29 A | 2010-03-19 A | 100% | 2009-05-29 | 2010-03-19 | 212d? | finish no earlier than 2010-03-19 | C1 | 1688h | 1688h | IMS_SCC-ICS | 23 | Nokia Siemens Networks | Peter.Leis@nsn.com | Rel-9 | 44 | Frederic |  |  |  |
| 6359 | 2062.4 | Stage 3 - IMS Centralized Services support via I1 interface | 271d? | 2009-03-06 A | 2010-03-19 A | 100% | 2009-03-06 | 2010-03-19 | 271d? | finish no earlier than 2010-03-19 | C1 | 2168h | 2168h | IMS_SCC-ICS_I1 | 22 | Huawei | Lili Yang(kadyyang@huawei.com) | Rel-9 | 43 | Frederic | IMS_SCC-ICS_I1 |  |  |
| 6360 | 2063 | **Service Specific Access Control in EPS** | 922d? | 2008-12-11 A | 2012-06-15 A | 100% | 2008-12-11 | 2012-06-15 | 922d? |  | S1; C1; R5 | 26000h | 26000h | SSAC | 22 | NTT DoCoMo | Frederic Thepot (thepot@docomolab-euro.com) | Rel-9 | 42 | Alain | SSAC |  |  |
| 6361 | 2063.1 | Stage 1 for Service Specific Access Control in EPS | 1d? | 2008-12-11 A | 2008-12-11 A | 100% | 2008-12-11 | 2008-12-11 | 1d? | start no earlier than 2008-12-11 | S1 | 8h | 8h | SSAC | 22 | NTT DoCoMo | Frederic Thepot (thepot@docomolab-euro.com) | Rel-9 | 42 | Alain |  |  |  |
| 6362 | 2063.2 | Stage 3 for Service Specific Access Control in EPS | 212d? | 2009-05-29 A | 2010-03-19 A | 100% | 2009-05-29 | 2010-03-19 | 212d? | finish no earlier than 2010-03-19 | C1 | 1696h | 1696h | SSAC | 23 | NTT DoCoMo | Hideyuki Yamashita (yamashitahi@s1.nttdocomo.co.jp) | Rel-9 | 44 | Frederic |  |  |  |
| 6363 | 2063.3 | Conformance Test Aspects - Service Specific Access Control | 272d? | 2011-06-07 A | 2012-06-15 A | 100% | 2011-06-07 | 2012-06-15 | 272d? | finish no earlier than 2012-06-15 | R5 | 2168h | 2168h | SSAC_UEConTest | 27 | NTT DoCoMo | Takao.Shimizu.rp@nttdocomo.com | Rel-9 | 52 | Ingbert | SSAC_UEConTest | RP-120447 |  |
| 6364 | 2064 | **Support for IMS Emergency Calls over GPRS and EPS** | 3785d? | 2000-01-03 A | 2014-06-13 A | 100% | 2000-01-03 | 2014-06-13 | 3785d? |  | S1; S2; S3; C1; C3; C4; R2; R3; R5; IETF | 293512h | 293512h | IMS_EMER_GPRS_EPS | 21 | Alcatel-Lucent | Deborah Barclay | Rel-9 | 38 | Maurice | IMS_EMER_GPRS_EPS |  | Public Safety (I-A) |
| 6365 | 2064.1 | Stage 1 for IMS Emergency Calls over GPRS and EPS | 239d? | 2008-01-14 A | 2008-12-11 A | 100% | 2008-01-14 | 2008-12-11 | 239d? | finish no earlier than 2008-12-11 | S1 | 1912h | 1912h | IMS_EMER_GPRS_EPS | 21 | Alcatel-Lucent | Deborah Barclay | Rel-9 | 38 | Alain |  |  | Public Safety (I-A) |
| 6366 | 2064.2 | Stage 2 for IMS Emergency Calls over GPRS and EPS | 364d? | 2008-01-14 A | 2009-06-04 A | 100% | 2008-01-14 | 2009-06-04 | 364d? | finish no earlier than 2009-06-04 | S2 | 2912h | 2912h | IMS_EMER_GPRS_EPS | 21 | Alcatel-Lucent | Deborah Barclay | Rel-9 | 38 | Maurice |  |  | Public Safety (I-A) |
| 6367 | 2064.3 | Security aspects for IMS Emergency Calls over GPRS and EPS | 391d? | 2008-12-12 A | 2010-06-10 A | 100% | 2008-12-12 | 2010-06-10 | 391d? | finish no earlier than 2010-03-25 | S3 | 3128h | 3128h | IMS_EMER_GPRS_EPS-Sec | 22 | Alcatel-Lucent | Deborah Barclay | Rel-9 | 42 | Mirko | IMS_EMER_GPRS_EPS-Sec |  | Public Safety (I-A) |
| 6368 | 2064.4 | **Stage 3 for IMS Emergency Calls over GPRS and EPS** | 801d? | 2009-05-29 A | 2012-06-15 A | 100% | 2009-05-29 | 2012-06-15 | 801d? |  | C1; C3; C4; R5 | 33331.7h | 33331.7h | IMS_EMER_GPRS_EPS | 23 | Alcatel-Lucent | Frank Alfano (falfano@alcatel-lucent.com) | Rel-9 | 44 | Frederic |  |  | Public Safety (I-A) |
| 6369 | 2064.4.1 | CT1 aspects - Stage 3 for IMS Emergency Calls over GPRS and EPS | 212d? | 2009-05-29 A | 2010-03-19 A | 100% | 2009-05-29 | 2010-03-19 | 212d? | finish no earlier than 2010-03-19 | C1 | 1696h | 1696h | IMS_EMER_GPRS_EPSC1 | 23 | Alcatel-Lucent | Frank Alfano (falfano@alcatel-lucent.com) | Rel-9 | 44 | Frederic |  |  | Public Safety (I-A) |
| 6370 | 2064.4.2 | Conformance Test Aspects - CT1 aspects for IMS Emergency Calls over GPRS and EPS | 532d? | 2010-06-04 A | 2012-06-15 A | 100% | 2010-06-04 | 2012-06-15 | 532d? | finish no earlier than 2012-06-15 | R5 | 4256h | 4256h | IMS_EMER_GPRS_EPS_UEConTest | 25 | Samsung | stoyan.baev@partner.samsung.com | Rel-9 | 48 | Ingbert | IMS_EMER_GPRS_EPS_UEConTest | RP-120445 | Public Safety (I-A) |
| 6371 | 2064.4.3 | CT3 aspects - Stage 3 for IMS Emergency Calls over GPRS and EPS | 82d? | 2009-05-29 A | 2009-09-18 A | 100% | 2009-05-29 | 2009-09-18 | 82d? | start no earlier than 2009-05-29 | C3 | 651.68h | 651.68h | IMS_EMER_GPRS_EPSC3 | 23 | Alcatel-Lucent | Frank Alfano (falfano@alcatel-lucent.com) | Rel-9 | 44 | Adrian |  |  | Public Safety (I-A) |
| 6372 | 2064.4.4 | CT4 aspects - Stage 3 for IMS Emergency Calls over GPRS and EPS | 137d? | 2009-05-29 A | 2009-12-04 A | 100% | 2009-05-29 | 2009-12-04 | 137d? | finish no earlier than 2009-12-04 | C4 | 1096h | 1096h | IMS_EMER_GPRS_EPSC4 | 23 | Alcatel-Lucent | Frank Alfano (falfano@alcatel-lucent.com) | Rel-9 | 44 | Kimmo |  |  | Public Safety (I-A) |
| 6373 | 2064.5 | Support for IMS Emergency Calls over LTE | 207d? | 2000-01-03 A | 2000-10-16 A | 100% | 2000-01-03 | 2000-10-16 | 207d? |  | R2; R3 | 3312h | 3312h | IMS_EMER_LTE | 22 | Alcatel-Lucent | Sudeep Palat (spalat@alcatel-lucent.com) | Rel-9 | 42 | Yong-Jun | IMS_EMER_LTE | RP-090698 | Public Safety (I-A) |
| 6374 | 2064.6 | Conformance Test Aspects – Support for IMS Emergency Calls over LTE | 187d? | 2010-03-25 A | 2010-12-10 A | 100% | 2010-03-25 | 2010-12-10 | 187d? | finish no earlier than 2010-12-10 | R5 | 1496h | 1496h | IMS_EMER_LTE_UEConTest | 24 | Ericsson | leif.mattisson@ericsson.com | Rel-9 | 47 | Ingbert | IMS_EMER_LTE_UEConTest | RP-101068 | Public Safety (I-A) |

Notes:
- 6351: CP#47 completed
- 6352: SP#42 completed / Impacted TSs and TRs: 22.101; 22.228
- 6353: -
- 6354: SP#57 Removal of the MSC server assisted mid-call feature from Rel-9 by 23.237CR#0433 (CT1 proposed moving this feature to Rel-10). SP#44 completed. TR 23.838 for Approval / Impacted TSs and TRs: 23.237; 23.292; 23.216; new 23.838
- 6355: CP#47 completed / Impacted TSs and TRs: 24.216; 24.229; 24.237
- 6356: -
- 6357: SP#44 completed. TR 23.883 for Information + Approval / Impacted TSs and TRs: 23.292; new 23.883
- 6358: CP#47 completed / Impacted TSs and TRs: 24.292; 24.604; 24.607; 24.608; 24.611; 24.623
- 6359: CP#47 completed / Impacted TSs and TRs: 24.237; 24.292; new 24.294
- 6360: CP#47 completed. Triggered by TR 22.986 Study on Service Specific Access Control in EPS. As EPS is a PS-Domain only system, Domain Specific Access Control (DSAC) doesn't apply, hence SSAC allows restriction of voice and non-voice calls separately
- 6361: SP#42 completed. If UE supports E-UTRA and IMS, SSAC is a mandatory Rel-9 function (during congestion in emergency case earthquake/tsunami improves mobile communications). / Impacted TSs and TRs: 22.011 CR0136
- 6362: CP#47 completed / Impacted TSs and TRs: 24.173; 27.007
- 6363: RP#56 completed. Testing for Stage 3 for Service Specific Access Control in EPS (24.173, 27.007) UID_440040 / Impacted TSs and TRs: 34.229-1; 34.229-2; 34.229-3
- 6364: RP#56 completed testing. CP#47 completed. SP#48 completed / Impacted TSs and TRs: GERAN; LTE
- 6365: SP#42 completed / Impacted TSs and TRs: 22.101
- 6366: SP#44 completed / Impacted TSs and TRs: 23.869; 23.060; 23.167; 23.203; 23.221; 23.228; 23.271; 23.401; 23.402
- 6367: SP#48 completed / Impacted TSs and TRs: 33.401; 33.402
- 6368: RP#56 completed testing. CP#47 completed / Impacted TSs and TRs: GERAN; LTE
- 6369: CP#47 completed / Impacted TSs and TRs: 23.122; 24.008; 24.229; 24.301; 24.302
- 6370: RP#56 completed / Impacted TSs and TRs: 34.108; 34.123-1; 34.123-2; 34.123-3; 34.229-1; 34.229-2; 34.229-3; 36.508; 36.523-1; 36.523-2; 36.523-3
- 6371: CP#45 completed / Impacted TSs and TRs: 29.212; 29.213; 29.214; 29.215
- 6372: CP#46 completed / Impacted TSs and TRs: 23.003; 23.008; 29.060; 29.272; 29.273; 29.274; 29.275; 29.276
- 6373: RP#45 completed / Impacted TSs and TRs: 36.331; 36.413
- 6374: RP#50 completed / Impacted TSs and TRs: 36.508; 36.523-1; 36.523-2; 36.523-3

| ID | WBS | Task | Type | Duration | Start | Finish | Complete | Baseline start | Baseline finish | Baseline duration | Constraint | Resources | Work | Actual work | Acronym | PCG approved | WI rapporteur name | WI rapporteur e-mail | Release | TSG approved | MCC resp | Special Focus Doc | Acronym_3GU_Export | Status Report |
| --- | --- | --- | --- | --- | --- | --- | --- | --- | --- | --- | --- | --- | --- | --- | --- | --- | --- | --- | --- | --- | --- | --- | --- | --- |
| 6375 | 2064.7 | **Single Radio Voice Call Continuity (SRVCC) support for IMS Emergency Calls** |  | 1511d? | 2008-09-18 A | 2014-06-13 A | 100% | 2008-09-18 | 2014-06-13 | 1511d? |  | S2; C1; C4; C3; IETF | 112300h | 112300h | IMS_EMER_GPRS_EPS-SRVCC | 21 | China Mobile | Yu Qing (Yuqing@chinamobile.com) | Rel-9 | 41 | Maurice | Public Safety (I-A) | IMS_EMER_GPRS_EPS-SRVCC |  |
| 6376 | 2064.7.1 | SRVCC support for IMS Emergency Calls |  | 322d? | 2008-09-18 A | 2009-12-10 A | 100% | 2008-09-18 | 2009-12-10 | 322d? | finish no earlier than 2009-12-10 | S2 | 2576h | 2576h | IMS_EMER_GPRS_EPS-SRVCC | 21 | China Mobile | Yu Qing (Yuqing@chinamobile.com) | Rel-9 | 41 | Maurice | Public Safety (I-A) |  |  |
| 6377 | 2064.7.2 | **CT aspects of SRVCC support for IMS Emergency Calls** |  | 1330d? | 2009-05-29 A | 2014-06-13 A | 100% | 2009-05-29 | 2014-06-13 | 1330d? |  | C1; C4; C3; IETF | 49284h | 49284h | IMS_EMER_GPRS_EPS-SRVCC | 24 | China Mobile | jiangyi@chinamobile.com | Rel-9 | 46 | Frederic | Public Safety (I-A) |  |  |
| 6378 | 2064.7.2.1 | CT1 aspects of SRVCC support for IMS Emergency Calls |  | 137d? | 2009-05-29 A | 2009-12-04 A | 100% | 2009-05-29 | 2009-12-04 | 137d? | finish no earlier than 2009-12-04 | C1 | 1096h | 1096h | IMS_EMER_GPRS_EPS-SRVCC | 23 | China Mobile | jiangyi@chinamobile.com | Rel-9 | 44 | Frederic | Public Safety (I-A) |  |  |
| 6379 | 2064.7.2.2 | CT4 aspects of SRVCC support for IMS Emergency Calls |  | 137d? | 2009-05-29 A | 2009-12-04 A | 100% | 2009-05-29 | 2009-12-04 | 137d? | finish no earlier than 2009-12-04 | C4 | 1096h | 1096h | IMS_EMER_GPRS_EPS-SRVCC | 23 | China Mobile | jiangyi@chinamobile.com | Rel-9 | 44 | Kimmo | Public Safety (I-A) |  |  |
| 6380 | 2064.7.2.3 | CT3 aspects of SRVCC support for IMS Emergency Calls |  | 1d? | 2009-12-04 A | 2009-12-04 A | 100% | 2009-12-04 | 2009-12-04 | 1d? | finish no earlier than 2009-12-04 | C3 | 8h | 8h | IMS_EMER_GPRS_EPS-SRVCC | 24 | China Mobile | jiangyi@chinamobile.com | Rel-9 | 46 | Kimmo | Public Safety (I-A) |  |  |
| 6381 | 2064.7.2.4 | (IETF) CT3 aspects of SRVCC support for IMS Emergency Calls (RFC 7254) |  | 568d? | 2012-04-20 A | 2014-06-13 A | 100% | 2012-04-20 | 2014-06-13 | 568d? | finish no earlier than 2014-06-13 | C3-IETF | 4524h | 4524h | IMS_EMER_GPRS_EPS-SRVCC | 29 | Andrew Allen | Andrew Allen | Rel-9 | 56 | Adrian | Public Safety (I-A) |  |  |
| 6382 | 2065 | **LCS for LTE and EPS** |  | 981d? | 2008-06-05 A | 2012-03-02 A | 100% | 2008-06-05 | 2012-03-02 | 981d? |  | S2; C1; C4; R2; R1; R3; R4; R5 | 83592h | 83592h | LCS_LTE_EPS | 22 |  |  | Rel-9 | 43 | Maurice | Public Safety (I-A) | LCS_LTE_EPS |  |
| 6383 | 2065.1 | **LCS Control Plane Solution for EPS** |  | 468d? | 2008-06-05 A | 2010-03-19 A | 100% | 2008-06-05 | 2010-03-19 | 468d? |  | S2; C4; C1 | 16712h | 16712h | LCS_EPS-CPS | 21 | Polaris Wireless | Robert Gross (rgross@polariswireless.com) | Rel-9 | 40 | Maurice | Public Safety (I-A) | LCS_EPS-CPS |  |
| 6384 | 2065.1.1 | Stage 2 for LCS Control Plane Solution for EPS |  | 261d? | 2008-06-05 A | 2009-06-04 A | 100% | 2008-06-05 | 2009-06-04 | 261d? | finish no earlier than 2009-06-04 | S2 | 2088h | 2088h | LCS_EPS-CPS | 21 | Polaris Wireless | Robert Gross (rgross@polariswireless.com) | Rel-9 | 40 | Maurice | Public Safety (I-A) |  |  |
| 6385 | 2065.1.2 | CT4 aspects of Control Plane LCS in the EPC |  | 212d? | 2009-05-29 A | 2010-03-19 A | 100% | 2009-05-29 | 2010-03-19 | 212d? | finish no earlier than 2010-03-19 | C4 | 1696h | 1696h | LCS_EPS-CPS | 23 | Polaris Wireless | Robert Gross (rgross@polariswireless.com) | Rel-9 | 44 | Kimmo | Public Safety (I-A) |  |  |
| 6386 | 2065.1.3 | CT1 aspects of Control Plane LCS in the EPC |  | 212d? | 2009-05-29 A | 2010-03-19 A | 100% | 2009-05-29 | 2010-03-19 | 212d? | finish no earlier than 2010-03-19 | C1 | 1696h | 1696h | LCS_EPS-CPS | 23 | Polaris Wireless | Robert Gross (rgross@polariswireless.com) | Rel-9 | 44 | Frederic | Public Safety (I-A) |  |  |
| 6387 | 2065.2 | Positioning Support for LTE | milestone | 0d? | 2008-12-05 A | 2008-12-05 A | 100% | 2008-12-05 | 2010-06-04 | 392d? | finish no earlier than 2010-06-04 | R2; R1; R3; R4 |  |  | LCS_LTE | 22 | Qualcomm | Nathan Tenny (ntenny@qualcomm.com) | Rel-9 | 42 | Yong-Jun | Public Safety (I-A) | LCS_LTE | RP-100442 |
| 6388 | 2065.3 | Conformance Test Aspects – Positioning Support for LTE |  | 512d? | 2010-03-19 A | 2012-03-02 A | 100% | 2010-03-19 | 2012-03-02 | 512d? | finish no earlier than 2012-03-02 | R5 | 4096h | 4096h | LCS_LTE_UEConTest | 24 | Qualcomm | Shubhang Vora (svoral@qualcomm.com) | Rel-9 | 47 | Ingbert | Public Safety (I-A) | LCS_LTE_UEConTest | RP-120034 |
| 6389 | 2066 | **MBMS support in EPS** |  | 921d? | 2008-06-05 A | 2011-12-09 A | 100% | 2008-06-05 | 2011-12-09 | 921d? |  | S2; S3; S5; C3; C4; R2; R3; R4; R5 | 82896h | 82896h | MBMS_EPS | 21 | China Mobile | Liu Hong (liuhongyfw@chinamobile.com) | Rel-9 | 40 | Maurice |  | MBMS_EPS |  |
| 6390 | 2066.1 | Stage 2 for MBMS support in EPS |  | 261d? | 2008-06-05 A | 2009-06-04 A | 100% | 2008-06-05 | 2009-06-04 | 261d? | finish no earlier than 2009-06-04 | S2 | 2088h | 2088h | MBMS_EPS | 21 | China Mobile | Liu Hong (liuhongyfw@chinamobile.com) | Rel-9 | 40 | Maurice |  |  |  |
| 6391 | 2066.2 | Security for MBMS support in EPS |  | 261d? | 2008-12-11 A | 2009-12-10 A | 100% | 2008-12-11 | 2009-12-10 | 261d? | finish no earlier than 2009-12-10 | S3 | 2088h | 2088h | MBMS_EPS | 22 | China Mobile | Liu Hong (liuhongyfw@chinamobile.com) | Rel-9 | 42 | Mirko |  |  |  |
| 6392 | 2066.3 | MBMS Charging in EPS |  | 201d? | 2009-03-06 A | 2009-12-10 A | 100% | 2009-03-06 | 2009-12-10 | 201d? | finish no earlier than 2009-12-10 | S5 | 1600h | 1600h | MBMS_EPS | 22 | ZTE | guo.wenjie1@zte.com.cn | Rel-9 | 43 | Mirko |  |  |  |
| 6393 | 2066.4 | CT4 aspects of MBMS support in EPS (Stage 3) |  | 137d? | 2009-05-29 A | 2009-12-04 A | 100% | 2009-05-29 | 2009-12-04 | 137d? | finish no earlier than 2009-12-04 | C4 | 1096h | 1096h | MBMS_EPS | 23 | China Mobile, ZTE | wangjingyf@chinamobile.com, lu.fei1@zte.com.cn | Rel-9 | 44 | Kimmo |  |  |  |
| 6394 | 2066.5 | CT3 aspects of MBMS support in EPS (Stage 3) |  | 137d? | 2009-05-29 A | 2009-12-04 A | 100% | 2009-05-29 | 2009-12-04 | 137d? | start no earlier than 2009-05-29 | C3 | 1096h | 1096h | MBMS_EPS | 23 | ZTE, China Mobile | zhou.xiaoyun@zte.com.cn, wangjingyf@chinamobile.com | Rel-9 | 44 | Adrian |  |  |  |
| 6395 | 2066.6 | MBMS support in LTE |  | 272d? | 2009-03-06 A | 2010-03-19 A | 100% | 2009-03-06 | 2010-03-19 | 272d? | finish no earlier than 2010-03-19 | R2; R3; R4 | 6528h | 6528h | MBMS_LTE | 22 | Huawei | arnaud.meylan@huawei.com | Rel-9 | 43 | Yong-Jun |  | MBMS_LTE | RP-100033 |
| 6396 | 2066.7 | Conformance Test Aspects – MBMS support in LTE |  | 262d? | 2010-12-10 A | 2011-12-09 A | 100% | 2010-12-10 | 2011-12-09 | 262d? | finish no earlier than 2011-12-09 | R5 | 2088h | 2088h | MBMS_LTE-UEConTest | 26 | Huawei | Zhang Xin (zhangxin0208@huawei.com) | Rel-9 | 50 | Ingbert |  | MBMS_LTE-UEConTest | RP-111437 |
| 6397 | 2067 | **Access Network Discovery and Selection Function enhancements** |  | 333d? | 2008-12-11 A | 2010-03-19 A | 100% | 2008-12-11 | 2010-03-19 | 333d? |  | S2; C1 | 7384h | 7384h | eANDSF | 22 | Motorola | Apostolis Salkintzis (salki@motorola.com) | Rel-9 | 42 | Maurice |  | eANDSF |  |
| 6398 | 2067.1 | Stage 2 for Access Network Discovery and Selection Function enhancements |  | 126d? | 2008-12-11 A | 2009-06-04 A | 100% | 2008-12-11 | 2009-06-04 | 126d? | finish no earlier than 2009-06-04 | S2 | 1008h | 1008h | eANDSF | 22 | Motorola | Apostolis Salkintzis (salki@motorola.com) | Rel-9 | 42 | Maurice |  |  |  |
| 6399 | 2067.2 | CT1 aspects of Access Network Discovery and Selection Function enhancements |  | 131d? | 2009-09-18 A | 2010-03-19 A | 100% | 2009-09-18 | 2010-03-19 | 131d? | finish no earlier than 2010-03-19 | C1 | 1048h | 1048h | eANDSF | 23 | Panasonic | benjamin.limck@sg.panasonic.com | Rel-9 | 45 | Frederic |  |  |  |

Notes:
- 6375: CP#56 added IETF dependency
- 6376: SP#46 completed / Impacted TSs and TRs: 23.870; 23.216; 23.237
- 6377: CP#46 completed
- 6378: CP#46 completed / Impacted TSs and TRs: 24.229; 24.237
- 6379: CP#46 completed / Impacted TSs and TRs: 29.205; 29.280
- 6380: CP#46 completed / Impacted TSs and TRs: 29.163
- 6381: CP#64 completed / Impacted TSs and TRs: RFC 7254 (was draft-montemurro-gsma-imei-urn)
- 6382: - / Impacted TSs and TRs: LTE
- 6383: Triggered by abandoned Study UID_380068 (FS_LCS_EPS). Linked to Feature UID_380064 Support for IMS Emergency Calls over GPRS and EPS
- 6384: SP#44 completed / Impacted TSs and TRs: 23.891; 23.271; 23.401; 23.402
- 6385: CP#47 completed (IANA registrations outstanding). Stage 3 SLs and SLg interfaces & transport of positioning messages between E-SMLC and MME in the scope of UID_420006 (Positioning Support for LTE) / Impacted TSs and TRs: 24.080; 29.002; 29.272; 29.230; new 24.171; 29.171; 29.172; 29.173
- 6386: CP#47 completed / Impacted TSs and TRs: 24.301
- 6387: RP#48 completed. UID_400038 (LCS Control Plane Solution for EPS) depends on this WI / Impacted TSs and TRs: 34.213; 36.133; 36.211; 36.214; 36.300; 36.305; 36.331; 36.355; 36.410; 36.413; 36.455; new 36.171
- 6388: RP#55 completed. RP#56 TS 37.571-4 v200 for Approval / Impacted TSs and TRs: 36.508; 36.509; new (37.571-1; 37.571-2; 37.571-3; 37.571-4; 37.571-5)
- 6389: RP#47 completed. SP#46, CP#46 completed / Impacted TSs and TRs: LTE
- 6390: SP#44 completed / Impacted TSs and TRs: 23.246
- 6391: SP#46 completed / Impacted TSs and TRs: 33.246
- 6392: SP#46 completed / Impacted TSs and TRs: 32.273; 32.251; 32.298; 32.299
- 6393: CP#46 completed / Impacted TSs and TRs: 29.274; 29.281; 23.007; 23.008
- 6394: CP#46 completed / Impacted TSs and TRs: 29.061
- 6395: RP#47 completed / Impacted TSs and TRs: 25.446; 36.101; 36.104; 36.141; 36.300; 36.304; 36.321; 36.322; 36.323; 36.331; 36.440; 36.441; 36.442; 36.444; 36.445
- 6396: RP#54 completed / Impacted TSs and TRs: 36.508; 36.521-1; 36.521-2; 36.523-1; 36.523-2; 36.523-3
- 6397: CP#47 completed. No new Rel-9 use cases defined. Implement service requirements not covered in Rel-8 / Impacted TSs and TRs: 22.278; SA3 33.402 CR#0055
- 6398: SP#44 completed / Impacted TSs and TRs: 23.402; 23.002
- 6399: CP#47 completed / Impacted TSs and TRs: 24.302; 24.312

| ID | WBS | Task | Duration | Start | Finish | Complete | Baseline start | Baseline finish | Baseline duration | Constraint | Resources | Work | Actual work | Acronym | PCG approved | WI rapporteur name | WI rapporteur e-mail | Release | TSG approved | MCC resp | Acronym_3GU_Export | Impacted TSs and TRs | Status Report |
| --- | --- | --- | --- | --- | --- | --- | --- | --- | --- | --- | --- | --- | --- | --- | --- | --- | --- | --- | --- | --- | --- | --- | --- |
| 6400 | 2068 | **Multiple PDN Connection to the Same APN for PMIP-based Interfaces** | 267d? | 2009-03-13 A | 2010-03-19 A | 100% | 2009-03-13 | 2010-03-19 | 267d? |  | S2; C4; C1 | 8392h | 8392h | MUPSAP | 22 | Samsung | erik.guttman@partner.samsung.com | Rel-9 | 43 | Maurice | MUPSAP |  |  |
| 6401 | 2068.1 | Stage 2 for Multiple PDN Connection to the Same APN for PMIP-based Interfaces | 61d? | 2009-03-13 A | 2009-06-04 A | 100% | 2009-03-13 | 2009-06-04 | 61d? | finish no earlier than 2009-06-04 | S2 | 488h | 488h | MUPSAP | 22 | Samsung | erik.guttman@partner.samsung.com | Rel-9 | 43 | Maurice |  | 23.060; 23.203; 23.401; 23.402 |  |
| 6402 | 2068.2 | CT4 aspects of Multiple PDN Connection to the Same APN for PMIP-based Interfaces | 56d? | 2009-09-18 A | 2009-12-04 A | 100% | 2009-09-18 | 2009-12-04 | 56d? | finish no earlier than 2009-12-04 | C4 | 448h | 448h | MUPSAP | 23 | Samsung | Surjyakanta Mohapatra (surjya.kanta@samsung.com) | Rel-9 | 45 | Kimmo |  | 29.275; 23.008; 29.282 |  |
| 6403 | 2068.3 | CT1 aspects of Multiple PDN Connection to the Same APN for PMIP-based Interfaces | 131d? | 2009-09-18 A | 2010-03-19 A | 100% | 2009-09-18 | 2010-03-19 | 131d? | finish no earlier than 2010-03-19 | C1 | 1048h | 1048h | MUPSAP | 23 | Samsung | Surjyakanta Mohapatra (surjya.kanta@samsung.com) | Rel-9 | 45 | Frederic |  | 24.302 |  |
| 6404 | 2069 | **System aspects of vocoder rate adaptation for LTE** | 1403.68d? | 2007-05-07 A | 2012-09-12 A | 100% | 2007-05-07 | 2012-09-12 | 1403.68d? |  | S2; S4; C1; C3; R2; IETF | 108798h | 108798h | LTEimp-Vocoder | 23 | Qualcomm | AC Mahendran (ac@qualcomm.com) | Rel-9 | 45 | Maurice | LTEimp-Vocoder | LTE |  |
| 6405 | 2069.1 | SA2 system aspects of vocoder rate adaptation for LTE | 81d? | 2009-06-04 A | 2009-09-24 A | 100% | 2009-06-04 | 2009-09-24 | 81d? | start no earlier than 2009-06-04 | S2 | 648h | 648h | LTEimp-Vocoder | 23 | Qualcomm | AC Mahendran (ac@qualcomm.com) | Rel-9 | 45 | Maurice |  | 23.401 CR#1103r3 |  |
| 6406 | 2069.2 | SA4 system aspects of vocoder rate adaptation for LTE | 136d? | 2009-06-04 A | 2009-12-10 A | 100% | 2009-06-04 | 2009-12-10 | 136d? | finish no earlier than 2009-12-07 | S4 | 1088h | 1088h | LTEimp-Vocoder | 23 | Qualcomm | Nikolai Leung | Rel-9 | 45 | Paolo |  | 26.114 |  |
| 6407 | 2069.3 | Vocoder rate adaptation for LTE | 81d? | 2009-05-30 A | 2009-09-18 A | 100% | 2009-05-30 | 2009-09-18 | 81d? | finish no earlier than 2009-09-18 | R2 | 648h | 648h | LTEimp-Vocoder | 23 | Alcatel-Lucent | Sudeep Palat (spalat@alcatel-lucent.com) | Rel-9 | 44 | Yong-Jun |  | 36.300 CR#0114 | RP-090704 |
| 6408 | 2069.4 | (IETF) SA4 system aspects of vocoder rate adaptation for LTE | 677.6d? | 2009-06-04 A | 2012-09-12 A | 100% | 2009-06-04 | 2012-09-12 | 677.6d? | finish no earlier than 2012-09-14 | S4-IETF | 5420.8h | 5420.8h | LTEimp-Vocoder | 27 | Lionel Morand |  | Rel-9 | 52 | Paolo |  | RFC 6679 (was draft-ietf-avtcore-ecn-for-rtp) |  |
| 6409 | 2069.5 | (IETF) CT aspects of vocoder rate adaptation for LTE | 1400.68d? | 2007-05-07 A | 2012-09-07 A | 100% | 2007-05-07 | 2012-09-07 | 1400.68d? | finish no earlier than 2012-09-07 | C1-IETF; C3-IETF; C4-IETF | 33616.3h | 33616.3h | LTEimp-Vocoder | 27 | Lionel Morand |  | Rel-9 | 52 | Frederic |  | RFC 6679 (was draft-ietf-avtcore-ecn-for-rtp) |  |
| 6410 | 2070 | Access Security Enhancements | 505d? | 2007-07-02 A | 2009-06-04 A | 100% | 2007-07-02 | 2009-06-04 | 505d? | finish no earlier than 2009-06-03 | S3 | 4040h | 4040h | ACCSEC2 | 17 | Ericsson | Bengt.Sahlin@ericsson.com | Rel-9 | 33 | Mirko | ACCSEC2 | 33.102; 43.020 |  |
| 6411 | 2071 | **Protection against Unsolicited Communication for IMS (PUCI)** | 322d? | 2008-09-18 A | 2009-12-10 A | 100% | 2008-09-18 | 2009-12-10 | 322d? |  | S3; S1 | 8216h | 8216h | PUCI | 21 | NEC | Anand R. Prasad (anand@bq.jp.nec.com) | Rel-9 | 41 | Alain | PUCI |  |  |
| 6412 | 2071.1 | Stage 1 for PUCI | 61d? | 2008-09-18 A | 2008-12-11 A | 100% | 2008-09-18 | 2008-12-11 | 61d? | finish no earlier than 2009-06-18 | S1 | 488h | 488h | PUCI | 21 | NEC | Anand R. Prasad (anand@bq.jp.nec.com) | Rel-9 | 41 | Alain |  | 22.228 |  |
| 6413 | 2071.2 | SA3 work on PUCI | 322d? | 2008-09-18 A | 2009-12-10 A | 100% | 2008-09-18 | 2009-12-10 | 322d? | finish no earlier than 2009-12-10 | S3 | 2576h | 2576h | PUCI | 21 | NEC | Anand R. Prasad (anand@bq.jp.nec.com) | Rel-9 | 41 | Mirko |  | New 33.937 |  |
| 6414 | 2072 | **IMS Media Plane Security** | 2757d? | 2002-03-01 A | 2012-09-14 A | 100% | 2009-03-13 | 2012-09-14 | 922d? |  | S3; C1; C4; C3; IETF | 89984h | 89984h | MEDIASEC | 22 | Vodafone | Peter.Howard@vodafone.com | Rel-9 | 43 | Mirko | MEDIASEC |  |  |
| 6415 | 2072.1 | SA3 aspects of IMS Media Plane Security | 271d? | 2009-03-13 A | 2010-03-25 A | 100% | 2009-03-13 | 2010-03-25 | 271d? | finish no earlier than 2010-03-25 | S3 | 2168h | 2168h | MEDIASEC | 22 | Vodafone | Peter.Howard@vodafone.com | Rel-9 | 43 | Mirko |  | New 33.828; 33.328 |  |
| 6416 | 2072.2 | (IETF) SA3, CT1, CT3 aspects of IMS Media Plane Security | 919d? | 2009-03-18 A | 2012-09-14 A | 100% | 2009-03-18 | 2012-09-14 | 919d? | finish no earlier than 2012-09-14 | S3-IETF; C1-IETF; C3-IETF | 22056h | 22056h | MEDIASEC | 27 | Peter Dawes |  | Rel-9 | 52 | Mirko |  | draft-dawes-dispatch-mediasec-parameter |  |
| 6417 | 2072.3 | (IETF) Security Considerations for WebRTC (draft-ietf-rtcweb-security) | 2757d? | 2002-03-01 A | 2012-09-14 A | 100% | 2009-03-18 | 2012-09-14 | 919d? | finish no earlier than 2012-09-14 | S3-IETF | 22056h | 22056h | MEDIASEC | 44 |  |  | Rel-9 | 87 | Mirko |  | RFC 8826 |  |
| 6418 | 2072.4 | **CN aspects of IMS Media Plane Security** | 186d? | 2009-09-18 A | 2010-06-04 A | 100% | 2009-09-18 | 2010-06-04 | 186d? |  | C1; C4; C3 | 6824h | 6824h | MEDIASEC_CORE | 23 | Vodafone | peter.dawes@vodafone.com | Rel-9 | 45 | Frederic | MEDIASEC_CORE |  |  |
| 6419 | 2072.4.1 | CT1 aspects of IMS Media Plane Security | 33d? | 2009-09-18 A | 2010-03-19 A | 100% | 2009-09-18 | 2010-03-19 | 33d? | finish no earlier than 2010-03-19 | C1 | 264h | 264h | MEDIASEC_CORE | 23 | Vodafone | peter.dawes@vodafone.com | Rel-9 | 45 | Frederic |  | 23.218; 24.229 |  |
| 6420 | 2072.4.2 | CT4 aspects of IMS Media Plane Security | 131d? | 2009-09-18 A | 2010-03-19 A | 100% | 2009-09-18 | 2010-03-19 | 131d? | finish no earlier than 2010-03-19 | C4 | 1048h | 1048h | MEDIASEC_CORE | 23 | Vodafone | peter.dawes@vodafone.com | Rel-9 | 45 | Kimmo |  | 29.238; 23.334; 29.334 |  |
| 6421 | 2072.4.3 | CT3 aspects of IMS Media Plane Security | 131d? | 2009-12-04 A | 2010-06-04 A | 100% | 2009-12-04 | 2010-06-04 | 131d? | finish no earlier than 2010-06-04 | C3 | 1048h | 1048h | MEDIASEC_CORE | 24 | Vodafone | peter.dawes@vodafone.com | Rel-9 | 46 | Adrian |  | 29.162 |  |
| 6422 | 2073 | **GBAPush enhancements (Generic push layer)** | 533d? | 2008-03-12 A | 2010-03-25 A | 100% | 2008-03-12 | 2010-03-25 | 533d? |  | S3 | 8528h | 8528h | eGBAPush | 23 | Ericsson | Rolf Blom | Rel-9 | 44 | Mirko | eGBAPush | New 33.224 |  |
| 6423 | 2073.1 | SA3 part of eGBAPush (Generic push layer) | 533d? | 2008-03-12 A | 2010-03-25 A | 100% | 2008-03-12 | 2010-03-25 | 533d? | finish no earlier than 2010-03-25 | S3 | 4264h | 4264h | eGBAPush | 21 | Ericsson | Rolf Blom | Rel-9 | 39 | Mirko |  | New 33.224 |  |
| 6424 | 2074 | Extended Identity Management | 136d? | 2009-06-04 A | 2009-12-10 A | 100% | 2009-06-04 | 2009-12-10 | 136d? | finish no earlier than 2009-12-10 | S3 | 1088h | 1088h | GBA-IdM | 23 | Nokia | Silke.Holtmanns@nokia.com | Rel-9 | 44 | Mirko | GBA-IdM | New 33.924; CT4 29.109 (added service code) |  |

Notes:
- 6400: CP#47 completed. Continues Rel-8 SAES Stage 2 UID_320005. Stage 1 in 22.278 (EPS Service requirements)
- 6401: SP#44 completed
- 6402: CP#46 completed
- 6403: CP#47 completed
- 6404: Triggered by RAN2 UID_440013 Vocoder rate adaptation for LTE
- 6405: SP#45 completed (CR adding support for Explicit Congestion Notification)
- 6406: SP#46 completed
- 6407: RP#45 completed
- 6408: SP#57 completed
- 6409: CP#57 completed
- 6410: SP#44 completed. Stopped TR 33.801. CRs 33.102,43.020 on A5/2 removal done long time ago. A5/4 introduction CRs will be done under UID_440057 128 bit encryption for GSM and GPRS. SP#26 approved WID (improved GERAN security)
- 6411: SP#46 TR 33.937 completed but no specification work done in Rel-9. Related work in OMA Categorization Based Content Screening
- 6412: SP#42 completed
- 6413: SP#46 completed. No normative work done in Rel-9
- 6414: -
- 6415: SP#47 completed
- 6416: CP#57 completed, ietf-draft discontinued, documented within 3GPP
- 6417: 9/4/21: RFC 8826 added;
- 6418: CP#48 completed
- 6419: CP#47 completed
- 6420: CP#47 completed
- 6421: CP#48 completed
- 6422: SP#43 umbrella to host 33.224, moved from Rel-8 to Rel-9. SP#47 completed
- 6423: SP#47 completed
- 6424: SP#46 completed. Stage 1 not identified (GBA Liberty Interworking has been outlined and GBAOpenID interworking is analogous)

| ID | WBS | Task | Duration | Start | Finish | Complete | Baseline start | Baseline finish | Baseline duration | Constraint | Resources | Work | Actual work | Acronym | PCG approved | WI rapporteur name | Release | TSG approved | MCC resp | Acronym_3GU_Export | PCG stopped | TSG stopped |
| --- | --- | --- | --- | --- | --- | --- | --- | --- | --- | --- | --- | --- | --- | --- | --- | --- | --- | --- | --- | --- | --- | --- |
| 6425 | 2075 | **Network Domain Security (NDS) enhancements to support backhaul security** | 924d? | 2009-06-04 A | 2012-12-07 A | 100% | 2009-06-04 | 2012-12-07 | 924d? |  | S3; IETF | 23452.8h | 23452.8h | NDS_Backhaul | 23 | Vodafone | Rel-9 | 44 | Mirko | NDS_Backhaul |  |  |
| 6426 | 2075.1 | SA3 part of Network Domain Security (NDS) enhancements to support backhaul security | 211d? | 2009-06-04 A | 2010-03-25 A | 100% | 2009-06-04 | 2010-03-25 | 211d? | finish no earlier than 2010-03-25 | S3 | 1688h | 1688h | NDS_Backhaul | 23 | Vodafone | Rel-9 | 44 | Mirko |  |  |  |
| 6427 | 2075.2 | (IETF) SA3 part of Network Domain Security (NDS) enhancements to support backhaul security | 740.6d? | 2009-06-04 A | 2012-12-07 A | 100% | 2009-06-04 | 2012-12-07 | 740.6d? | finish no earlier than 2012-12-07 | S3-IETF | 5924.8h | 5924.8h | NDS_Backhaul | 27 | Bengt Sahlin | Rel-9 | 52 | Mirko |  |  |  |
| 6428 | 2075.3 | Deleted - CT4 part of Network Domain Security (NDS) enhancements to support backhaul security | 132d? | 2009-06-04 A | 2009-12-04 A | 100% | 2009-06-04 | 2009-12-04 | 132d? | finish no earlier than 2009-12-04 | C4 | 1056h | 1056h | NDS_Backhaul | 23 | Vodafone | Rel-9 | 44 | Kimmo |  | PCG-24 | CP-46 |
| 6429 | 2076 | **128 bit encryption for GSM and GPRS** | 136d? | 2009-06-04 A | 2009-12-10 A | 100% | 2009-06-04 | 2009-12-10 | 136d? |  | S3; C1; C4; G2; G3new | 10392h | 10392h | A5/4-GEA4 | 23 | Ericsson | Rel-9 | 44 | Mirko | A5/4-GEA4 |  |  |
| 6430 | 2076.1 | SA3 part of 128 bit encryption for GSM and GPRS | 136d? | 2009-06-04 A | 2009-12-10 A | 100% | 2009-06-04 | 2009-12-10 | 136d? | finish no earlier than 2010-01-06 | S3 | 1088h | 1088h | A5/4-GEA4 | 23 | Ericsson | Rel-9 | 44 | Mirko |  |  |  |
| 6431 | 2076.2 | CT1 part of 128 bit encryption for GSM and GPRS | 77d? | 2009-06-04 A | 2009-09-18 A | 100% | 2009-06-04 | 2009-09-18 | 77d? | start no earlier than 2009-06-04 | C1 | 616h | 616h | A5/4-GEA4 | 23 | Ericsson | Rel-9 | 44 | Frederic |  |  |  |
| 6432 | 2076.3 | CT4 part of 128 bit encryption for GSM and GPRS | 136d? | 2009-06-04 A | 2009-12-10 A | 100% | 2009-06-04 | 2009-12-10 | 136d? | start no earlier than 2009-06-04 | C4 | 1088h | 1088h | A5/4-GEA4 | 23 | Ericsson | Rel-9 | 44 | Kimmo |  |  |  |
| 6433 | 2076.4 | GERAN2 part of 128 bit encryption for GSM and GPRS | 67d? | 2009-06-04 A | 2009-09-04 A | 100% | 2009-06-04 | 2009-09-04 | 67d? | finish no earlier than 2009-09-04 | G2 | 536h | 536h | A5/4-GEA4 | 23 | Ericsson | Rel-9 | 44 | Gert |  |  |  |
| 6434 | 2076.5 | GERAN3new (testing) part of 128 bit encryption for GSM and GPRS | 122d? | 2009-06-04 A | 2009-11-20 A | 100% | 2009-06-04 | 2009-11-20 | 122d? | finish no earlier than 2009-11-20 | G3new | 976h | 976h | A5/4-GEA4 | 23 | Ericsson | Rel-9 | 44 | Ingbert |  |  |  |
| 6435 | 2076.6 | Deleted - SA2 part of 128 bit encryption for GSM and GPRS | 81d? | 2009-06-04 A | 2009-09-24 A | 100% | 2009-06-04 | 2009-09-24 | 81d? | finish no earlier than 2009-09-24 | S2 | 648h | 648h | A5/4-GEA4 | 23 | Ericsson | Rel-9 | 44 | Maurice |  | PCG-23 | SP-45 |
| 6436 | 2077 | Timed Graphics | 337d? | 2008-12-11 A | 2010-03-25 A | 100% | 2008-12-11 | 2010-03-25 | 337d? | finish no earlier than 2010-03-25 | S4 | 2696h | 2696h | TG | 22 | Ericsson | Rel-9 | 42 | Paolo | TG |  |  |
| 6437 | 2078 | Managing MTSI Media Adaptation | 197d? | 2009-03-12 A | 2009-12-10 A | 100% | 2009-03-12 | 2009-12-10 | 197d? | finish no earlier than 2009-12-10 | S4 | 1568h | 1568h | M3A | 22 | Samsung | Rel-9 | 43 | Paolo | M3A |  |  |
| 6438 | 2079 | **PSS and MBMS Aspects** | 272d? | 2009-03-12 A | 2010-03-25 A | 100% | 2009-03-12 | 2010-03-25 | 272d? |  | S4 | 6512h | 6512h | PMA | 23 | Ericsson, Nokia | Rel-9 | 44 | Paolo | PMA |  |  |
| 6439 | 2079.1 | PSS and MBMS extensions | 271d? | 2009-03-12 A | 2010-03-25 A | 100% | 2009-03-12 | 2010-03-25 | 271d? | finish no earlier than 2010-03-25 | S4 | 2168h | 2168h | PMA-MBS_Ext | 22 | Ericsson | Rel-9 | 43 | Paolo | PMA-MBS_Ext |  |  |
| 6440 | 2079.2 | Improved Video Support for PSS and MBMS | 271d? | 2009-03-12 A | 2010-03-25 A | 100% | 2009-03-12 | 2010-03-25 | 271d? | finish no earlier than 2010-03-25 | S4 | 2168h | 2168h | PMA-IVS | 22 | Nokia | Rel-9 | 43 | Paolo | PMA-IVS |  |  |
| 6441 | 2080 | IMS based PSS and MBMS User Service extensions | 197d? | 2009-03-12 A | 2009-12-10 A | 100% | 2009-03-12 | 2009-12-10 | 197d? | finish no earlier than 2009-12-10 | S4 | 1576h | 1576h | IMS_PSS_MBMS_US_EXT | 22 | Ericsson | Rel-9 | 43 | Paolo | IMS_PSS_MBMS_US_EXT |  |  |
| 6442 | 2081 | Syndicated Feed Reception within 3GPP environments | 136d? | 2009-06-04 A | 2009-12-10 A | 100% | 2009-06-04 | 2009-12-10 | 136d? | start no earlier than 2009-06-04 | S4 | 1088h | 1088h | SFR | 23 | Ericsson | Rel-9 | 44 | Paolo | SFR |  |  |
| 6443 | 2082 | Distortion Measurement Test Methods and Requirements | 131d? | 2009-09-24 A | 2010-03-25 A | 100% | 2009-09-24 | 2010-03-25 | 131d? | finish no earlier than 2010-03-25 | S4 | 1048h | 1048h | DTMR | 23 | Motorola | Rel-9 | 45 | Paolo | DTMR |  |  |
| 6444 | 2083 | **Rel-9 Operations, Administration, Maintenance and Provisioning (OAM&P)** | 601d? | 2008-02-22 A | 2010-06-10 A | 100% | 2008-02-22 | 2010-06-10 | 601d? |  | S5 | 36890.4h | 36890.4h | OAM9 | 22 |  | Rel-9 | 42 | Mirko | OAM9 |  |  |
| 6445 | 2083.1 | **Rel-9 Network Infrastructure Management** | 337d? | 2008-12-11 A | 2010-03-25 A | 100% | 2008-12-11 | 2010-03-25 | 337d? |  | S5 | 8760h | 8760h | OAM9-NIM | 22 |  | Rel-9 | 42 | Mirko | OAM9-NIM |  |  |
| 6446 | 2083.1.1 | Software Management for Network Elements | 336d? | 2008-12-11 A | 2010-03-25 A | 100% | 2008-12-11 | 2010-03-25 | 336d? | finish no earlier than 2010-03-25 | S5 | 2688h | 2688h | OAM9-NE_SWM | 22 | Huawei, Nokia Siemens Networks | Rel-9 | 42 | Mirko | OAM9-NE_SWM |  |  |
| 6447 | 2083.1.2 | Service Oriented Architecture (SOA) for IRP | 211d? | 2009-06-04 A | 2010-03-25 A | 100% | 2009-06-04 | 2010-03-25 | 211d? | finish no earlier than 2010-03-25 | S5 | 1688h | 1688h |  | 23 | Ericsson, Nokia Siemens Networks | Rel-9 | 44 | Mirko |  |  |  |
| 6448 | 2083.1.3 | IRP SOAP Solution Sets continuation from Rel-8 | 211d? | 2009-06-04 A | 2010-03-25 A | 100% | 2009-06-04 | 2010-03-25 | 211d? | finish no earlier than 2010-03-25 | S5 | 1688h | 1688h |  | 23 | Ericsson | Rel-9 | 44 | Mirko |  |  |  |

Notes:
- 6425: Continuation of Rel-8 UID_390044 SAE security architecture. Covers gaps in backhaul security in SAE (also applicable to UTRAN and GERAN backhaul) / WI rapporteur e-mail: Peter.Howard@vodafone.com
- 6426: SP#47 completed / Impacted TSs and TRs: 33.102; 33.210; 33.310; 33.401; 33.402 / WI rapporteur e-mail: Peter.Howard@vodafone.com
- 6427: CP#58 completed / Impacted TSs and TRs: RFC 6712 (was draft-ietf-pkix-cmp-transport-protocols)
- 6428: CP#46 completed. No impact on CT4 specs / WI rapporteur e-mail: Peter.Howard@vodafone.com
- 6429: Allow 128 as an alternative to 64 bit keys (Stage 2/3 + Test spec) / WI rapporteur e-mail: Karl Norrman
- 6430: SP#46 completed / Impacted TSs and TRs: 33.102.43.020; New 55.226 / WI rapporteur e-mail: Karl Norrman
- 6431: CP#45 completed / Impacted TSs and TRs: 24.008.44.064 / WI rapporteur e-mail: Karl Norrman
- 6432: CP#46 completed. Kc128 enhancements are carried as UMTS keys => no impact on CT4 29.002, 29.060 / WI rapporteur e-mail: Karl Norrman
- 6433: GP#43 WID approved + completed / Impacted TSs and TRs: 44.018.48.008.48.018.48.058 / WI rapporteur e-mail: Karl Norrman
- 6434: GP#44 completed. GP#43 WID approved / Impacted TSs and TRs: 51.010 / WI rapporteur e-mail: Karl Norrman
- 6435: SP#45 work stopped/abandoned / Impacted TSs and TRs: 23.060 / WI rapporteur e-mail: Karl Norrman
- 6436: SP#47 completed. Provide graphics in parallel to a video stream (without requiring an umbrella scene descriptor such as 3GPP DIMS in TS 26.142) / Impacted TSs and TRs: 26.114; 26.140; 26.234; 26.244; 26.245; 26.346; New 26.430 / WI rapporteur e-mail: clinton.priddle@ericsson.com
- 6437: SP#46 completed. Work extending Rel-8 UID_34041 MTSI Video - Dynamic Rate Adaptation/Signalling of Image Size. Update speech/video adaptation algorithms used by network to control MTSI client terminal in congestion or poor transmission conditions. / Impacted TSs and TRs: 26.114 / WI rapporteur e-mail: kyunghun.jung@samsung.com
- 6438: Umbrella WI / WI rapporteur e-mail: Clinton.Priddle@ericsson.com, imed.bouazizi@nokia.com
- 6439: SP#47 completed. Extends Rel-8 UID_34043 (PSS_MBMS_OMTV) & ensures compatibility with UID_34046 (IMS_PSS_MBMS_US) / Impacted TSs and TRs: 26.234; 26.346 / WI rapporteur e-mail: Clinton.Priddle@ericsson.com
- 6440: SP#47 completed / Impacted TSs and TRs: 26.234; 26.244; 26.346; new 26.903 / WI rapporteur e-mail: imed.bouazizi@nokia.com
- 6441: SP#46 completed. Work extending Rel-8 UID_34046 (IMS_PSS_MBMS_US), SA2 UID_410034 IMSSCC-SPI (IMS Service Continuity Enhancements: Service, Policy and Interactions) / Impacted TSs and TRs: 26.237 / WI rapporteur e-mail: Markus Kampmann
- 6442: SP#46 completed. TS 26.150v100 for Approval. RSS optimized for mobile use. Reuse/reference OMA's enabler DCD. / Impacted TSs and TRs: New 26.150 / WI rapporteur e-mail: Thorsten.Lohmar@ericsson.com
- 6443: SP#47 completed / Impacted TSs and TRs: 26.131; 26.132 / WI rapporteur e-mail: Stephen Kendall (wcsk01@motorola.com)
- 6444: OAM9 is an umbrella Feature also for OAM&P related TEI9 type of changes that are not part of any other dedicated feature/WI / Impacted TSs and TRs: 30.819
- 6445: SP#42 umbrella BB created to host OAM WIs
- 6446: SP#47 completed / Impacted TSs and TRs: 32.531; 32.532; 32.533; new 32.537 / WI rapporteur e-mail: Bidipta Das (bidipta@huawei.com), Clemens Suerbaum (clemens.suerbaum@nsn.com)
- 6447: SP#47 completed (covering SOA Architecture & SOA-supporting Solution Set). Triggered by UID_400029 Study on Service Oriented Architecture (SOA) for IRP (TR 32.824) / Impacted TSs and TRs: 32.101; 32.102; 32.150 / WI rapporteur e-mail: edwin.tse@ericsson.com, Jörg Schmidt (joerg@cox.net)
- 6448: SP#47 completed. Continuation of Rel-8 UID_400030 IRP SOAP Solution Sets / Impacted TSs and TRs: New (32.127/ 327/ 337/ 357/ 387/ 397/ 447/ 397/ 447/ 507/ 537); 32.121.32.122.32.123.32.32.321.32.322.32.323.32.325.32.331.32.332.32.333.32.335.32.351.32.352.32.353.32.381.32.382.32.383.32.385.32.391.32.392.32.393.32.395.32.441.32.442.32.443 / WI rapporteur e-mail: John Power

| ID | WBS | Task | Duration | Start | Finish | Complete | Baseline start | Baseline finish | Baseline duration | Constraint | Resources | Work | Actual work | Acronym | PCG approved | Release | TSG approved | MCC resp | Acronym_3GU_Export | Impacted TSs and TRs | WI rapporteur name | Special Focus Doc | PCG stopped | TSG stopped |
| --- | --- | --- | --- | --- | --- | --- | --- | --- | --- | --- | --- | --- | --- | --- | --- | --- | --- | --- | --- | --- | --- | --- | --- | --- |
| 6449 | 2083.2 | **Rel-9 Performance Management** | 327d? | 2009-03-12 A | 2010-06-10 A | 100% | 2009-03-12 | 2010-06-10 | 327d? |  | S5 | 7890.41h | 7890.41h | OAM9-PM | 22 | Rel-9 | 42 | Mirko | OAM9-PM |  |  |  |  |  |
| 6450 | 2083.2.1 | Enhancement of UTRAN Performance Measurements | 136d? | 2009-06-04 A | 2009-12-10 A | 100% | 2009-06-04 | 2009-12-10 | 136d? | start no earlier than 2009-06-04 | S5 | 1088h | 1088h |  | 23 | Rel-9 | 44 | Mirko |  | 32.405 | China Mobile |  |  |  |
| 6451 | 2083.2.2 | Enhancement of E-UTRAN Performance Measurements | 327d? | 2009-03-12 A | 2010-06-10 A | 100% | 2009-03-12 | 2010-06-10 | 327d? | finish no earlier than 2010-06-10 | S5 | 2616h | 2616h |  | 22 | Rel-9 | 43 | Mirko |  | 32.425 | Motorola, Huawei |  |  |  |
| 6452 | 2083.2.3 | Enhancement of EPC Performance Measurements | 197d? | 2009-03-12 A | 2009-12-10 A | 100% | 2009-03-12 | 2009-12-10 | 197d? | finish no earlier than 2010-03-25 | S5 | 1570.41h | 1570.41h |  | 22 | Rel-9 | 43 | Mirko |  | 32.426 | China Mobile |  |  |  |
| 6453 | 2083.3 | **Rel-9 Self-Organizing Networks (SON) - OAM aspects** | 601d? | 2008-02-22 A | 2010-06-10 A | 100% | 2008-02-22 | 2010-06-10 | 601d? |  | S5 | 11736h | 11736h | OAM9-SON | 22 | Rel-9 | 43 | Mirko | OAM9-SON |  |  | SON |  |  |
| 6454 | 2083.3.1 | SON self-optimization management (moved from Rel-8 LTE_SON-OAM) | 600d? | 2008-02-22 A | 2010-06-10 A | 100% | 2008-02-22 | 2010-06-10 | 600d? | finish no earlier than 2010-06-10 | S5 | 4800h | 4800h |  | 21 | Rel-9 | 39 | Mirko |  | 32.425; new (32.521; 32.522; 32.523; 32.525) | Huawei | SON |  |  |
| 6455 | 2083.3.2 | Automatic Radio Network Configuration Data Preparation | 266d? | 2009-06-04 A | 2010-06-10 A | 100% | 2009-06-04 | 2010-06-10 | 266d? | finish no earlier than 2010-06-10 | S5 | 2128h | 2128h |  | 23 | Rel-9 | 44 | Mirko |  | 32.501; 32.502; 32.503; 32.505; new 32.507 | Nokia Siemens Networks | SON |  |  |
| 6456 | 2083.4 | Rel-9 Subscription Management (SuM) evolution | 266d? | 2009-06-04 A | 2010-06-10 A | 100% | 2009-06-04 | 2010-06-10 | 266d? | finish no earlier than 2010-06-10 | S5 | 2128h | 2128h | OAM9-SuM | 23 | Rel-9 | 44 | Mirko | OAM9-SuM | 32.140; 32.141; 32.152; 32.172; 32.175 | Ericsson |  |  |  |
| 6457 | 2083.5 | Deleted - Rel-9 Trace | 196d? | 2009-03-13 A | 2009-12-10 A | 100% | 2009-03-13 | 2009-12-10 | 196d? | finish no earlier than 2009-12-10 | S5 | 1568h | 1568h | OAM9-Trace | 22 | Rel-9 | 42 | Mirko | OAM9-Trace |  |  |  | PCG-24 | SP-46 |
| 6458 | 2084 | Rel-9 Charging Management small Enhancements | 211d? | 2009-06-04 A | 2010-03-25 A | 100% | 2009-06-04 | 2010-03-25 | 211d? |  | S5 | 1688h | 1688h | CH9 | 23 | Rel-9 | 44 | Mirko | CH9 | 30.819 |  |  |  |  |
| 6459 | 2085 | **CS-IBCF and CS-TrGW definition in 3GPP specifications** | 472d? | 2008-05-30 A | 2010-03-19 A | 100% | 2008-05-30 | 2010-03-19 | 472d? |  | C3; C4 | 14490.3h | 14490.3h | CS-IBCF | 21 | Rel-9 | 40 | Adrian | CS-IBCF |  | Telecom Italia |  |  |  |
| 6460 | 2085.1 | CT3 aspects of CS-IBCF and CS-TrGW definition in 3GPP specifications | 472d? | 2008-05-30 A | 2010-03-19 A | 100% | 2008-05-30 | 2010-03-19 | 472d? | finish no earlier than 2009-12-04 | C3 | 3770.34h | 3770.34h | CS-IBCF | 21 | Rel-9 | 40 | Adrian |  | 29.235 | Telecom Italia |  |  |  |
| 6461 | 2085.2 | CT4 aspects of CS-IBCF and CS-TrGW definition in 3GPP specifications | 396d? | 2008-05-30 A | 2009-12-04 A | 100% | 2008-05-30 | 2009-12-04 | 396d? | finish no earlier than 2009-12-04 | C4 | 3168h | 3168h | CS-IBCF | 21 | Rel-9 | 40 | Kimmo |  | 23.231; 29.232; new 29.238 | Telecom Italia |  |  |  |
| 6462 | 2086 | **IMS – Interconnection Border Control Function (IBCF) – Transition Gateway (TrGW); Ix Interface; Stage 3** | 322d? | 2008-09-12 A | 2009-12-04 A | 100% | 2008-09-12 | 2009-12-04 | 322d? |  | C4; C3 | 10086.4h | 10086.4h | IMS_IBCF | 21 | Rel-9 | 41 | Kimmo | IMS_IBCF |  | Alcatel-Lucent |  |  |  |
| 6463 | 2086.1 | CT4 part of IMS – Interconnection Border Control Function (IBCF) – Transition Gateway (TrGW); Ix Interface; Stage 3 | 321d? | 2008-09-12 A | 2009-12-04 A | 100% | 2008-09-12 | 2009-12-04 | 321d? | finish no earlier than 2009-12-04 | C4 | 2568h | 2568h | IMS_IBCF | 21 | Rel-9 | 41 | Kimmo |  | new 29.238 | Alcatel-Lucent |  |  |  |
| 6464 | 2086.2 | CT3 part of IMS – Interconnection Border Control Function (IBCF) – Transition Gateway (TrGW); Ix Interface; Stage 3 | 295.8d? | 2008-09-12 A | 2009-12-04 A | 100% | 2008-09-12 | 2009-12-04 | 295.8d? | finish no earlier than 2010-03-19 | C3 | 2366.4h | 2366.4h | IMS_IBCF | 21 | Rel-9 | 41 | Adrian |  | 29.162; 29.235 | Alcatel-Lucent |  |  |  |
| 6465 | 2087 | IMS Application Level Gateway Control Function (ALGCF) – IMS Access Media Gateway (IMA-MGW); Iq Interface; Stage 2 and Stage 3 | 321d? | 2008-09-12 A | 2009-12-04 A | 100% | 2008-09-12 | 2009-12-04 | 321d? | finish no earlier than 2009-12-04 | C4 | 2568h | 2568h | IMS_AGCF | 21 | Rel-9 | 41 | Kimmo | IMS_AGCF | New 23.334; 29.334 | Alcatel-Lucent |  |  |  |
| 6466 | 2088 | **Enhancements of IMS Customized Alerting Tone (CAT) Service** | 392d? | 2008-12-05 A | 2010-06-04 A | 100% | 2008-12-05 | 2010-06-04 | 392d? |  | C1 | 5846.4h | 5846.4h | eCAT | 22 | Rel-9 | 42 | Frederic | eCAT |  | China Mobile |  |  |  |
| 6467 | 2088.1 | Stage 3 for Enhancements of IMS Customized Alerting Tone (CAT) Service | 391d? | 2008-12-05 A | 2010-06-04 A | 100% | 2008-12-05 | 2010-06-04 | 391d? | finish no earlier than 2010-06-04 | C1 | 3128h | 3128h | eCAT-SS | 22 | Rel-9 | 42 | Frederic | eCAT-SS | 24.182 | China Mobile |  |  |  |
| 6468 | 2089 | **Completion of IMS Restoration Procedures** | 212d? | 2009-05-29 A | 2010-03-19 A | 100% | 2009-05-29 | 2010-03-19 | 212d? |  | C3; C4; C1 | 10176h | 10176h | eIMS_RP | 23 | Rel-9 | 44 | Kimmo | eIMS_RP |  | Ericsson |  |  |  |
| 6469 | 2089.1 | CT4 aspects of Completion of IMS Restoration Procedures | 212d? | 2009-05-29 A | 2010-03-19 A | 100% | 2009-05-29 | 2010-03-19 | 212d? | finish no earlier than 2010-03-19 | C4 | 1696h | 1696h | eIMS_RP | 23 | Rel-9 | 44 | Kimmo |  | 23.380; 23.820 | Ericsson |  |  |  |
| 6470 | 2089.2 | CT1 aspects of Completion of IMS Restoration Procedures | 212d? | 2009-05-29 A | 2010-03-19 A | 100% | 2009-05-29 | 2010-03-19 | 212d? | finish no earlier than 2010-03-19 | C1 | 1696h | 1696h | eIMS_RP | 23 | Rel-9 | 44 | Kimmo |  | 24.229 | Ericsson |  |  |  |
| 6471 | 2089.3 | CT3 aspects of Completion of IMS Restoration Procedures | 212d? | 2009-05-29 A | 2010-03-19 A | 100% | 2009-05-29 | 2010-03-19 | 212d? | finish no earlier than 2010-03-19 | C3 | 1696h | 1696h | eIMS_RP | 24 | Rel-9 | 46 | Kimmo |  | 29.061; 29.212; 29.213; 29.214; 29.215 | Ericsson |  |  |  |
| 6472 | 2090 | **IMS Stage 3 IETF Protocol Alignment - phase 3** | 1458d? | 2009-05-29 A | 2014-12-05 A | 100% | 2009-05-29 | 2014-12-05 | 1455d? |  | C1; IETF | 40216h | 40216h | IMSProtoc3 | 23 | Rel-9 | 44 | Frederic | IMSProtoc3 |  | Alcatel-Lucent |  |  |  |
| 6473 | 2090.1 | CT1 aspects of IMS Stage 3 - IETF Protocol Alignment - phase 3 | 212d? | 2009-05-29 A | 2010-03-19 A | 100% | 2009-05-29 | 2010-03-19 | 212d? | finish no earlier than 2010-03-19 | C1 | 1696h | 1696h | IMSProtoc3 | 23 | Rel-9 | 44 | Frederic |  | 23.218; 24.229; 24.930 | Alcatel-Lucent |  |  |  |
| 6474 | 2090.2 | (IETF) CT1 IMS Stage 3 - IETF Protocol Alignment (RFC 7329) | 1242d? | 2009-05-29 A | 2014-12-05 A | 100% | 2009-05-29 | 2014-12-05 | 1240d? | finish no earlier than 2014-12-09 | C1-IETF | 9936h | 9936h | IMSProtoc3 | 27 | Rel-9 | 52 | Frederic |  | RFC 7329 (was draft-kaplan-insipid-session-id) | christer.holmberg@ericsson.com |  |  |  |
| 6475 | 2090.3 | (IETF) CT1 IMS Stage 3 - IETF Protocol Alignment (RFC 7044) | 659d? | 2011-09-13 A | 2014-03-07 A | 100% | 2011-09-13 | 2014-03-07 | 659d? | finish no earlier than 2014-02-10 | C1-IETF | 5256h | 5256h | IMSProtoc3 | 27 | Rel-9 | 53 | Frederic |  | RFC 7044 (was draft-ietf-sipcore-rfc4244bis) | christer.holmberg@ericsson.com |  |  |  |

Notes:
- 6449: SP#42 umbrella BB created to host OAM WIs
- 6450: SP#46 completed / WI rapporteur e-mail: liangshuangchun@cmdi.chinamobile.com, lijian@chinamobile.com, Bao Haitao
- 6451: SP#48 completed / WI rapporteur e-mail: Yizhi Yao (yzyao@motorola.com),Lan Zou (zlan@huawei.com)
- 6452: SP#46 completed / WI rapporteur e-mail: Li Jian (lijian@chinamobile.com), Liang Shuangchun (liangshuangchun@cmdi.chinamobile.com)
- 6453: SP#43 umbrella BB created to host OAM WIs
- 6454: SP#48 completed / WI rapporteur e-mail: Lan Zou (zlan@huawei.com)
- 6455: SP#48 completed / WI rapporteur e-mail: clemens.suerbaum@nsn.com
- 6456: SP#48 completed / WI rapporteur e-mail: frode.nergard@ericsson.com
- 6457: SP#46 stopped (no work in Rel-9)
- 6458: CH9 is an umbrella Feature also for OAM&P related TEI9 type of changes that are not part of any other dedicated feature/WI
- 6459: CP#47 completed. Rel-8 UID_380061 (Ipinterc) covers Stage 1 in SA1 22.101, 22.228 / WI rapporteur e-mail: mauro.ficaccio@telecomitalia.it
- 6460: CP#47 completed / WI rapporteur e-mail: mauro.ficaccio@telecomitalia.it
- 6461: CP#46 completed / WI rapporteur e-mail: mauro.ficaccio@telecomitalia.it
- 6462: CP#46 completed / WI rapporteur e-mail: bruno.landais@alcatel-lucent.fr
- 6463: CP#46 completed / WI rapporteur e-mail: bruno.landais@alcatel-lucent.fr
- 6464: CP#46 completed / WI rapporteur e-mail: bruno.landais@alcatel-lucent.fr
- 6465: CP#46 completed / WI rapporteur e-mail: bruno.landais@alcatel-lucent.fr
- 6466: CP#48 completed. Stage 1 in 22.182 / WI rapporteur e-mail: Jiang Yi
- 6467: CP#48 completed / WI rapporteur e-mail: Jiang Yi
- 6468: CP#47 completed. Continuation of Rel-8 Feature UID_400012 IMS Restoration Procedures / WI rapporteur e-mail: Emiliano Merino (emiliano.merino@ericsson.com)
- 6469: CP#47 completed / WI rapporteur e-mail: Emiliano Merino (emiliano.merino@ericsson.com)
- 6470: CP#47 completed / WI rapporteur e-mail: Emiliano Merino (emiliano.merino@ericsson.com)
- 6471: CP#47 completed / WI rapporteur e-mail: Emiliano Merino (emiliano.merino@ericsson.com)
- 6472: CP#47 completed / WI rapporteur e-mail: Keith Drage (drage@alcatel-lucent.com)
- 6473: CP#47 completed / WI rapporteur e-mail: Keith Drage (drage@alcatel-lucent.com)
- 6474: CP#65 completed / WI rapporteur e-mail: christer.holmberg@ericsson.com
- 6475: CP#63 completed / WI rapporteur e-mail: christer.holmberg@ericsson.com

| ID | WBS | Task | Type | Duration | Start | Finish | Complete | Baseline start | Baseline finish | Baseline duration | Constraint | Resources | Work | Actual work | Acronym | PCG approved | WI rapporteur name | WI rapporteur e-mail | Release | TSG approved | MCC resp | Acronym_3GU_Export | TSG stopped | Special Focus Doc | Status Report |
| --- | --- | --- | --- | --- | --- | --- | --- | --- | --- | --- | --- | --- | --- | --- | --- | --- | --- | --- | --- | --- | --- | --- | --- | --- | --- |
| 6476 | 2091 | **Operational description of the Inter-IMS Network to Network Interface (II-NNI)** |  | 1460d? | 2009-05-29 A | 2014-12-09 A | 100% | 2009-05-29 | 2014-12-05 | 1455d? |  | C3; IETF | 58408h | 58408h | II-NNI | 23 | Orange | sebastien.daudet@orange-ftgroup.com | Rel-9 | 44 | Adrian | II-NNI |  |  |  |
| 6477 | 2091.1 | Operational description of the Inter-IMS Network to Network Interface |  | 267d? | 2009-05-29 A | 2010-06-04 A | 100% | 2009-05-29 | 2010-06-04 | 267d? | start no earlier than 2009-05-29 | C3 | 2136h | 2136h | II-NNI | 23 | Orange |  | Rel-9 | 44 | Adrian |  |  |  |  |
| 6478 | 2091.2 | (IETF) Operational description of the Inter-IMS Network to Network Interface (RFC 7329) |  | 633d? | 2012-04-20 A | 2014-09-12 A | 100% | 2012-04-20 | 2014-12-05 | 693d? | finish no earlier than 2014-09-12 | C3-IETF | 5040h | 5040h | II-NNI | 29 | christer.holmberg@ericsson.com | christer.holmberg@ericsson.com | Rel-9 | 56 | Adrian |  |  |  |  |
| 6479 | 2091.3 | (IETF) Operational description of the Inter-IMS Network to Network Interface (RFC 7316) |  | 634d? | 2012-04-20 A | 2014-09-12 A | 100% | 2012-04-20 | 2014-12-05 | 694d? | finish no earlier than 2014-12-09 | C3-IETF | 5064h | 5064h | II-NNI | 29 | Keith Drage | Keith Drage | Rel-9 | 56 | Adrian |  |  |  |  |
| 6480 | 2091.4 | (IETF) Operational description of the Inter-IMS Network to Network Interface |  | 696d? | 2012-04-20 A | 2014-12-09 A | 100% | 2012-04-20 | 2014-12-05 | 694d? | finish no earlier than 2014-12-09 | C3-IETF | 5560h | 5560h | II-NNI | 29 | Roland Jesske | Roland Jesske | Rel-9 | 56 | Adrian |  |  |  |  |
| 6481 | 2091.5 | (IETF) Operational description of the Inter-IMS Network to Network Interface |  | 696d? | 2012-04-20 A | 2014-12-09 A | 100% | 2012-04-20 | 2014-12-05 | 694d? | finish no earlier than 2014-12-09 | C3-IETF | 5536h | 5536h | II-NNI | 29 | Roland Jesske | Roland Jesske | Rel-9 | 56 | Adrian |  |  |  |  |
| 6482 | 2091.6 | (IETF) Operational description of the Inter-IMS Network to Network Interface |  | 697d? | 2012-04-20 A | 2014-12-09 A | 100% | 2012-04-20 | 2014-12-05 | 695d? | finish no earlier than 2014-12-09 | C3-IETF | 5560h | 5560h | II-NNI | 29 | Keith Drage | Keith Drage | Rel-9 | 56 | Adrian |  |  |  |  |
| 6483 | 2091.7 | Deleted - (IETF) Operational description of the Inter-IMS Network to Network Interface |  | 433d? | 2012-04-20 A | 2013-12-06 A | 100% | 2012-04-20 | 2014-12-05 | 694d? | finish no earlier than 2013-12-06 | C3-IETF | 3456h | 3456h | II-NNI | 29 | Peter Dawes | peter.dawes@vodafone.com | Rel-9 | 56 | Adrian |  | SP-69 |  |  |
| 6484 | 2091.8 | Deleted - (IETF) Operational description of the Inter-IMS Network to Network Interface (avasarala-dispatch-comm-div-notification) |  | 340d? | 2013-03-01 A | 2014-06-13 A | 100% | 2013-03-01 | 2014-06-13 | 340d? | finish no earlier than 2014-06-13 | C3-IETF | 2696h | 2696h | II-NNI | 30 | Andrew Allen | Andrew Allen | Rel-9 | 59 | Adrian |  | SP-69 |  |  |
| 6485 | 2092 | Definition of Ml interface for Control Plane LCS (Stage 3) |  | 131d? | 2009-09-18 A | 2010-03-19 A | 100% | 2009-09-18 | 2010-03-19 | 131d? | finish no earlier than 2010-03-19 | C1 | 1048h | 1048h | EMC2 | 23 | Alcatel-Lucent | Keith Drage (drage@alcatel-lucent.com) | Rel-9 | 45 | Frederic | EMC2 |  | Public Safety (I-A) |  |
| 6486 | 2093 | PCC enhancements |  | 56d? | 2009-09-18 A | 2009-12-04 A | 100% | 2009-09-18 | 2009-12-04 | 56d? | finish no earlier than 2009-12-04 | C3 | 448h | 448h | PCC-Enh | 23 | Huawei | Wei Weihua (weiwh@huawei.com) | Rel-9 | 45 | Adrian | PCC-Enh |  |  |  |
| 6487 | 2094 | 3GPP IMS Conferencing Management Object (MO) |  | 2d? | 2009-12-03 A | 2009-12-04 A | 100% | 2009-12-03 | 2009-12-04 | 2d? | start no earlier than 2009-12-03 | C1 | 16h | 16h | IMS_ConfMO | 24 |  |  | Rel-9 | 46 | Frederic | IMS_ConfMO |  |  |  |
| 6488 | 2095 | In Case of Emergency (ICE) Graphics |  | 3d? | 2010-03-17 A | 2010-03-19 A | 100% | 2010-03-17 | 2010-03-19 | 3d? | finish no earlier than 2010-03-19 | C6 | 24h | 24h | ICE_Graphics | 24 | Sagem-Orga | heiko.kruse@sagem-orga.com | Rel-9 | 47 | Xavier | ICE_Graphics |  |  |  |
| 6489 | 2096 | **Rel-9 Improvements of the Radio Interface** |  | 397d? | 2008-09-12 A | 2010-03-19 A | 100% | 2008-09-12 | 2010-03-19 | 397d? |  | RP; GP | 19744h | 19744h | RInImp9 | 21 |  |  | Rel-9 | 41 | Issam | RInImp9 |  |  |  |
| 6490 | 2096.1 | LCR TDD UE OTA Performance Requirements |  | 186d? | 2008-09-12 A | 2009-05-29 A | 100% | 2008-09-12 | 2009-05-29 | 186d? | finish no earlier than 2009-05-29 | R4 | 1488h | 1488h | RInImp9-RFLCROTA | 21 | RITT | Wu Xiang (wuxiang@chinattl.com) | Rel-9 | 41 | Issam | RInImp9-RFLCROTA |  |  | RP-090389 |
| 6491 | 2096.2 | **RF requirements for Multicarrier and Multi-RAT BS** |  | 347d? | 2008-11-21 A | 2010-03-19 A | 100% | 2008-11-21 | 2010-03-19 | 347d? |  | R4; G1 | 10336h | 10336h | RInImp9-RFmulti | 21 | Ericsson | Johan.skold@ericsson.com | Rel-9 | 41 | Issam | RInImp9-RFmulti |  |  |  |
| 6492 | 2096.2.1 | RAN4 part of RF requirements for Multicarrier and Multi RAT BS |  | 337d? | 2008-12-05 A | 2010-03-19 A | 100% | 2008-12-05 | 2010-03-19 | 337d? | finish no earlier than 2010-03-19 | R4 | 2696h | 2696h | RInImp9-Rfmulti | 22 | Ericsson | johan.skold@ericsson.com | Rel-9 | 42 | Issam |  |  |  | RP-100027 |
| 6493 | 2096.2.2 | GERAN part of RF requirements for Multicarrier and Multi RAT BS |  | 261d? | 2008-11-21 A | 2009-11-20 A | 100% | 2008-11-21 | 2009-11-20 | 261d? | finish no earlier than 2009-11-20 | G1 | 2088h | 2088h | RInImp9-RFmulti-GERAN | 22 | Ericsson | mats.y.samuelsson@ericsson.com | Rel-9 | 40 | Paolo | RInImp9-RFmulti-GERAN |  |  |  |
| 6494 | 2096.3 | Extended UMTS/LTE 800 MHz | milestone | 0d? | 2008-12-05 A | 2008-12-05 A | 100% | 2008-12-05 | 2009-09-18 | 207d? |  | R4; R2; R3 |  |  | RInImp9-UMTSLTE800 | 22 | NTT DoCoMo | Shingo Suwa (suwas@nttdocomo.co.jp) | Rel-9 | 42 | Issam | RInImp9-UMTSLTE800 |  |  | RP-090687 |
| 6495 | 2096.4 | UMTS/LTE 800 MHz for Europe | milestone | 0d? | 2009-03-06 A | 2009-03-06 A | 100% | 2009-03-06 | 2010-03-19 | 272d? | finish no earlier than 2010-03-19 | R4; R2; R3 |  |  | RInImp9-UMTSLTE800EU | 22 | Ericsson | olav.queseth@ericsson.com | Rel-9 | 43 | Issam | RInImp9-UMTSLTE800EU |  |  | RP-100028 |
| 6496 | 2096.5 | Performance requirement for LCR TDD with UE speeds up to 350 km/h |  | 196d? | 2009-03-06 A | 2009-12-04 A | 100% | 2009-03-06 | 2009-12-04 | 196d? | finish no earlier than 2009-12-04 | R4 | 1568h | 1568h | RInImp9-LCRTDD350 | 22 | CATT | Yuexia Song (songyuexia@catt.cn) | Rel-9 | 43 | Issam | RInImp9-LCRTDD350 |  |  | RP-091035 |
| 6497 | 2096.6 | Extended UMTS/LTE 1500 MHz | milestone | 0d? | 2009-05-30 A | 2009-05-30 A | 100% | 2009-05-30 | 2010-03-19 | 211d? | finish no earlier than 2010-03-19 | R4; R2; R3 |  |  | UMTSLTE1500 | 23 | NTT DoCoMo | Shingo Suwa (suwas@nttdocomo.co.jp) | Rel-9 | 44 | Issam | UMTSLTE1500 |  |  | RP-100029 |
| 6498 | 2097 | **Rel-9 Improvements of the Radio Interface - UE Conformance Testing** |  | 350d? | 2009-05-19 A | 2010-09-17 A | 100% | 2009-05-19 | 2010-09-17 | 350d? |  | R5 | 8184h | 8184h |  | 23 |  |  | Rel-9 | 44 | Ingbert |  |  |  |  |
| 6499 | 2097.1 | Conformance Test Aspects – UMTS/LTE in 800 MHz for Europe |  | 350d? | 2009-05-19 A | 2010-09-17 A | 100% | 2009-05-19 | 2010-09-17 | 350d? | finish no earlier than 2010-09-17 | R5 | 2800h | 2800h | RInImp-UEConTest-UMTSLTE800EU | 23 | Ericsson | fredrik.sundstrom@ericsson.com | Rel-9 | 44 | Ingbert | RInImp-UEConTest-UMTSLTE800EU |  |  | RP-100736 |
| 6500 | 2097.2 | Conformance Test Aspects – Extended UMTS/LTE 1500 MHz |  | 186d? | 2009-09-18 A | 2010-06-04 A | 100% | 2009-09-18 | 2010-06-04 | 186d? | finish no earlier than 2010-06-04 | R5 | 1488h | 1488h | UMTSLTE1500_UEConTest | 23 | NTT DoCoMo | Nguyen Dung Dao (dao@nttdocomo.co.jp) | Rel-9 | 45 | Ingbert | UMTSLTE1500_UEConTest |  |  | RP-100487 |
| 6501 | 2097.3 | TDD UE Over The Air (Antenna) conformance testing methodology |  | 81d? | 2009-05-30 A | 2009-09-18 A | 100% | 2009-05-30 | 2009-09-18 | 81d? | finish no earlier than 2009-09-18 | R5 | 648h | 648h | UEAnt_TDDTest | 23 | CATR | Qu Yan (quyan@emcite.com) | Rel-9 | 44 | Ingbert | UEAnt_TDDTest |  |  | RP-090727 |
| 6502 | 2097.4 | Conformance Test Aspects – Performance requirement for LCR TDD with UE speeds up to 350 km/h |  | 56d? | 2010-03-19 A | 2010-06-04 A | 100% | 2010-03-19 | 2010-06-04 | 56d? | finish no earlier than 2010-06-04 | R5 | 448h | 448h | RInImp9-LCRTDD350_UEConTest | 24 | CATT | Xiaozhong Chen (chexiaozhong@datangmobile.cn) | Rel-9 | 47 | Ingbert | RInImp9-LCRTDD350_UEConTest |  |  | RP-100496 |
| 6503 | 2098 | Conformance Test Aspects – SMS over IMS in E-UTRAN |  | 131d? | 2009-09-18 A | 2010-03-19 A | 100% | 2009-09-18 | 2010-03-19 | 131d? | finish no earlier than 2010-06-18 | R5 | 1048h | 1048h | SMSoverIMS_UEConTest | 23 | Alcatel-Lucent | Nidal Khrais (khrais@alcatel-lucent.com) | Rel-9 | 45 | Ingbert | SMSoverIMS_UEConTest |  |  | RP-100072 |

Notes:
- 6476: -
- 6477: CP#48 completed / Impacted TSs and TRs: 29.165
- 6478: CP#65 complete / Impacted TSs and TRs: RFC 7329 (was draft-kaplan-insipid-session-id)
- 6479: CP#65 complete / Impacted TSs and TRs: RFC 7316 (was draft-vanelburg-dispatch-private-network-ind)
- 6480: In RFC Editors Queue. Dec.14: 75->90¦7/3/16: 90%->100 / Impacted TSs and TRs: draft-ietf-salud-alert-info-urns
- 6481: In RFC Editors Queue. Mar15: 90->100%. RFC updated (was draft-ietf-cuss-sip-uui). Jun 15: RFC 7433 (was draft-ietf-cuss-sip-uui) / Impacted TSs and TRs: RFC 7433
- 6482: In RFC Editors Queue. Dec.14: 75->90. Mar15: 90->100%. RFC updated (was draft-ietf-cuss-sip-uui-isdni). June 15: RFC 7434 (was draft-ietf-cuss-sip-uui-isdn) / Impacted TSs and TRs: RFC 7434
- 6483: CP#62 removed from Rel-8 to Rel-11. Not completed internet-draft / Impacted TSs and TRs: Rel-12 remains draft-dawes-sipping-debug
- 6484: CP#64 Draft removed from 3GPP documentation / Impacted TSs and TRs: draft-avasarala-dispatch-comm-div-notification
- 6485: CP#47 completed [Stage 3 for Rel-7 Emergency Calls (EMC1)]. Related to Rel-9 UID_400038 LCS Control Plane Solution for EPS. Stage 2 in Rel-9 UID_400038 (23.271), UID_410037 (23.167) / Impacted TSs and TRs: 24.229
- 6486: CP#46 completed / Impacted TSs and TRs: 29.212; 29.213; 29.215
- 6487: CP#46 completed. Linked to Rel-6 UID_11051 (IMS Management objects) under the Feature UID_32021 (IMS Phase 2). MO compatible with OMA DM v1.2 & upwards and defined using OMA DM Device Description Framework (OMA-ERELD _DM-V1_2) / Impacted TSs and TRs: New 24.166
- 6488: CP#47 approved WID and completed. Added capability to store ICE graphical information (picture). Linked to CT6 Rel-8 ICE Feature UID_380059 In Case of Emergency numbers storage and easy access on UICC / Impacted TSs and TRs: 31.102 CR#0433
- 6489: RP#41 umbrella Feature created to host Rel-9 WIs / Impacted TSs and TRs: GERAN; UTRA; LTE
- 6490: RP#44 completed technical work (RAN4 internal TR abandoned) / Impacted TSs and TRs: UTRA (no 25.8xy produced)
- 6491: RP#47 completed. RF requirements specification applicable to Multi-Standard Radio (MSR) Base Station with multiple carriers and/or multiple 3GPP Radio Access Technologies (RAT) / Impacted TSs and TRs: GERAN; UTRA; LTE
- 6492: RP#48 completed / Impacted TSs and TRs: UTRA; LTE 25.104; 25.105; 36.104; new 37.104; 37.113; 37.141; 37.900
- 6493: GP#44 Core spec completed. GP#40 WID approved / Impacted TSs and TRs: GERAN 45.005; 51.021
- 6494: RP#45 completed / Impacted TSs and TRs: UTRA; LTE 25.101; 25.104; 25.113; 25.133; 34.124; 36.101; 36.104; 36.113; 36.124; 36.133; 36.141; 25.306; 25.307; 25.331; 36.331; 25.461; 25.466; new 36.800
- 6495: RP#47 completed / Impacted TSs and TRs: UTRA; LTE 25.101; 25.104; 25.113; 25.133; 25.141; 34.124; 36.101; 36.104; 36.113; 36.124; 36.133; 36.141; new 36.810; 25.306; 25.307; 25.331; 36.331; 25.461; 25.466
- 6496: RP#46 completed / Impacted TSs and TRs: UTRA 25.102; 25.105; 25.142
- 6497: RP#47 completed. For potential deployment in Japan / Impacted TSs and TRs: UTRA; LTE 25.101; 25.104; 25.113; 25.133; 25.141; 25.306; 25.307; 25.331; 25.461; 25.466; 34.124; 36.101; 36.104; 36.113; 36.124; 36.133; 36.141; 36.331; new (36.821; 36.307)
- 6498: - / Impacted TSs and TRs: UTRA; LTE
- 6499: RP#49 completed. Testing for UID_430009 UMTS/LTE 800 MHz for Europe / Impacted TSs and TRs: UTRA; LTE 34.108; 34.121-1; 34.121-2; 36.508; 36.521-1; 36.521-2; 36.521-3
- 6500: RP#48 completed / Impacted TSs and TRs: UTRA; LTE 34.108; 34.121-1; 34.121-2; 34.123-1; 34.123-2; 36.508; 36.521-1; 36.521-2; 36.521-3; 36.523-1; 36.523-2; 36.523-3
- 6501: RP#45 completed. Finalized TDD UE test methodology based on R4 TR 25.914 (UE and MS antenna performance evaluation method) and TS 25.144 Over the Air (Antenna) minimum performance requirements for the speech mode (terminal close to head) / Impacted TSs and TRs: UTRA 34.114
- 6502: RP#48 completed. Testing for UID_430010 Performance requirement for LCR TDD with UE speeds up to 350 km/h / Impacted TSs and TRs: UTRA 34.122
- 6503: RP#47 completed / Impacted TSs and TRs: LTE 34.229-1; 34.229-2; 34.229-3

| ID | WBS | Task | Type | Duration | Start | Finish | Complete | Baseline start | Baseline finish | Baseline duration | Constraint | Resources | Work | Actual work | PCG approved | Release | TSG approved | MCC resp | Acronym | WI rapporteur name | WI rapporteur e-mail | Status Report | Acronym_3GU_Export | Special Focus Doc |
| --- | --- | --- | --- | --- | --- | --- | --- | --- | --- | --- | --- | --- | --- | --- | --- | --- | --- | --- | --- | --- | --- | --- | --- | --- |
| 6504 | 2099 | **Rel-9 RAN improvements** |  | 395d? | 2009-03-06 A | 2010-09-08 A | 100% | 2000-01-03 | 2010-03-19 | 2667d? |  | RP | 12640h | 12640h | 22 | Rel-9 | 43 | Issam |  |  |  |  |  |  |
| 6505 | 2099.1 | Dual-Cell HSUPA | milestone | 0d? | 2009-03-06 A | 2009-03-06 A | 100% | 2009-03-06 | 2010-03-19 | 272d? | finish no earlier than 2010-03-19 | R1; R2; R3; R4 |  |  | 22 | Rel-9 | 43 | Patrick | RANimp-DC_HSUPA | Nokia Siemens Networks | Karri Ranta-aho (karri.ranta-aho@nsn.com) | RP-100030 | RANimp-DC_HSUPA |  |
| 6506 | 2099.2 | Support for different bands for Dual-Cell HSDPA | milestone | 0d? | 2009-03-06 A | 2009-03-06 A | 100% | 2009-03-06 | 2009-12-04 | 197d? |  | R4; R2; R3 |  |  | 22 | Rel-9 | 43 | Issam | RANimp-MultiBand_DC_HSDPA | Nokia Siemens Networks | Tuomo Säynäjäkangas (tuomo.saynajakangas@nsn.com) | RP-091038 | RANimp-MultiBand_DC_HSDPA |  |
| 6507 | 2099.3 | Combination of DC-HSDPA with MIMO | milestone | 0d? | 2009-03-06 A | 2009-03-06 A | 100% | 2009-03-06 | 2009-12-04 | 197d? |  | R1; R2; R3; R4 |  |  | 22 | Rel-9 | 43 | Patrick | RANimp-DC_MIMO | Ericsson | johan.bergman@ericsson.com | RP-091039 | RANimp-DC_MIMO |  |
| 6508 | 2099.4 | Transmit Antenna Array (TxAA) extension for non-MIMO UEs | milestone | 0d? | 2009-03-06 A | 2009-03-06 A | 100% | 2009-03-06 | 2009-12-04 | 197d? |  | R1; R2; R3; R4 |  |  | 22 | Rel-9 | 43 | Patrick | RANimp-TxAA_nonMIMO | Nokia | Arto Lehti (arto.lehti@nokia.com) | RP-091040 | RANimp-TxAA_nonMIMO |  |
| 6509 | 2099.5 | Cell Portion for 1.28 Mcps TDD |  | 395d? | 2009-03-06 A | 2010-09-08 A | 100% | 2000-01-03 | 2000-07-07 | 136d? | finish no earlier than 2009-03-06 | R3; R1; R4 | 9480h | 9480h | 23 | Rel-9 | 44 | Juha | CP_LCRTDD | CATT | Ying Zhang (zhangying2@datangmobile.cn) | RP-091041 | CP_LCRTDD |  |
| 6510 | 2100 | **Rel-9 RAN improvements - UE Conformance Testing** |  | 588d? | 2010-09-17 A | 2012-12-07 A | 100% | 2010-09-17 | 2012-12-07 | 588d? |  | R5 | 11848h | 11848h | 25 | Rel-9 | 49 | Ingbert |  |  |  |  |  |  |
| 6511 | 2100.1 | Conformance Test Aspects – Combination of DC-HSDPA with MIMO |  | 186d? | 2010-09-17 A | 2011-06-03 A | 100% | 2010-09-17 | 2011-06-03 | 186d? | finish no earlier than 2011-06-03 | R5 | 1488h | 1488h | 25 | Rel-9 | 49 | Ingbert | RANimp-DC_MIMO_UEConTest | Ericsson | leif.mattisson@ericsson.com | RP-110510 | RANimp-DC_MIMO_UEConTest |  |
| 6512 | 2100.2 | Conformance Test Aspects – Dual-Cell HSUPA |  | 453d? | 2011-03-18 A | 2012-12-07 A | 100% | 2011-03-18 | 2012-12-07 | 453d? | finish no earlier than 2012-12-07 | R5 | 3624h | 3624h | 26 | Rel-9 | 51 | Ingbert | RANimp-DC_HSUPA_UEConTest | Ericsson | leif.mattisson@ericsson.com | RP-121524 | RANimp-DC_HSUPA_UEConTest |  |
| 6513 | 2100.3 | Conformance Test Aspects – Support for different bands for Dual-Cell HSDPA |  | 254d? | 2011-03-18 A | 2012-03-02 A | 100% | 2011-03-18 | 2012-03-02 | 254d? | finish no earlier than 2012-03-02 | R5 | 2032h | 2032h | 26 | Rel-9 | 51 | Ingbert | RANimp-MultiBand_DC_HSDPA_UEConTest | Ericsson | leif.mattisson@ericsson.com | RP-120036 | RANimp-MultiBand_DC_HSDPA_UEConTest |  |
| 6514 | 2101 | **LTE improvements** |  | 587d? | 2009-03-06 A | 2011-06-03 A | 100% | 2009-03-06 | 2011-06-03 | 587d? |  | R1; R2; R4; R5 | 21840h | 21840h | 22 | Rel-9 | 42 | Patrick | LTEimp |  |  |  | LTEimp |  |
| 6515 | 2101.1 | LTE Pico NodeB RF Requirements |  | 196d? | 2009-03-06 A | 2009-12-04 A | 100% | 2009-03-06 | 2009-12-04 | 196d? | finish no earlier than 2010-03-05 | R4 | 1568h | 1568h | 22 | Rel-9 | 43 | Issam | LTEimp-Pico_eNB-RF | Huawei | Liyan Yin (yinliyan@huawei.com) | RP-091045 | LTEimp-Pico_eNB-RF |  |
| 6516 | 2101.2 | Enhanced Dual-Layer transmission for LTE | milestone | 0d? | 2009-03-06 A | 2009-03-06 A | 100% | 2009-03-06 | 2010-03-19 | 272d? | finish no earlier than 2010-03-18 | R1; R2; R4 |  |  | 22 | Rel-9 | 43 | Patrick | LTEimp-eDL | China Mobile | Xu Xiaodong (xuxiaodong@chinamobile.com) | RP-100034 | LTEimp-eDL |  |
| 6517 | 2101.3 | UE Conformance Test Aspects – Enhanced Dual-layer transmission for LTE TDD |  | 186d? | 2010-09-17 A | 2011-06-03 A | 100% | 2010-09-17 | 2011-06-03 | 186d? | finish no earlier than 2011-06-03 | R5 | 1488h | 1488h | 25 | Rel-9 | 49 | Ingbert | LTEimp-eDL_UEConTest | China Mobile | Shanpeng Xiao (xiaoshanpeng@chinamobile.com) | RP-110509 | LTEimp-eDL_UEConTest |  |
| 6518 | 2102 | Rel-9 Self-Organizing Networks (SON) | milestone | 0d? | 2009-03-06 A | 2009-03-06 A | 100% | 2009-03-06 | 2010-03-19 | 272d? | finish no earlier than 2010-03-19 | R3; R2 |  |  | 22 | Rel-9 | 42 | Juha | SON | Nokia Siemens Networks | krzysztof.kordybach@nsn.com | RP-100038 | SON | SON |
| 6519 | 2103 | **AGNSS Performances and Testing Procedures** |  | 787d? | 2008-05-16 A | 2011-05-20 A | 100% | 2008-05-16 | 2011-05-20 | 787d? |  | G1; G3new | 22664h | 22664h | 20 | Rel-9 | 38 | Paolo | AGNSSPTP | Thales | Michel.monnerat@thalesaleniaspace.com |  | AGNSSPTP |  |
| 6520 | 2103.1 | AGNSS Minimum Performances |  | 472d? | 2008-05-16 A | 2010-03-05 A | 100% | 2008-05-16 | 2010-03-05 | 472d? | finish no earlier than 2010-03-05 | G1 | 3776h | 3776h | 20 | Rel-9 | 38 | Paolo | AGNSSPTP-Perfreq | Thales | Michel.monnerat@thalesaleniaspace.com |  | AGNSSPTP-Perfreq |  |
| 6521 | 2103.2 | AGNSS Testing Procedures |  | 787d? | 2008-05-16 A | 2011-05-20 A | 100% | 2008-05-16 | 2011-05-20 | 787d? | finish no earlier than 2011-05-20 | G3new | 6296h | 6296h | 20 | Rel-9 | 38 | Ingbert | AGNSSPTP-MStest | Thales | Michel.monnerat@thalesaleniaspace.com |  | AGNSSPTP-MStest |  |
| 6522 | 2104 | **Voice services over Adaptive Multi-user channels on One Slot** |  | 860d? | 2008-11-21 A | 2012-03-02 A | 100% | 2008-11-21 | 2012-03-02 | 860d? |  | GP; G1; G2; G3new | 71592h | 71592h | 22 | Rel-9 | 42 | Paolo | VAMOS | Nokia Siemens Networks, China Mobile | juergen.hofmann@nsn.com, liuxiaoyu@chinamobile.com |  | VAMOS |  |
| 6523 | 2104.1 | Stage 2 for Voice services over Adaptive Multi-user channels on One Slot |  | 392d? | 2008-11-21 A | 2010-05-21 A | 100% | 2008-11-21 | 2010-05-21 | 392d? | finish no earlier than 2010-05-21 | GP; G1; G2 | 9408h | 9408h | 22 | Rel-9 | 40 | Paolo | VAMOS | Nokia Siemens Networks, China Mobile | juergen.hofmann@nsn.com, liuxiaoyu@chinamobile.com |  |  |  |
| 6524 | 2104.2 | Stage 3 for Voice services over Adaptive Multi-user channels on One Slot |  | 596d? | 2008-11-24 A | 2011-03-04 A | 100% | 2008-11-24 | 2011-03-04 | 596d? | finish no earlier than 2011-03-04 | GP; G1; G2 | 14304h | 14304h | 22 | Rel-9 | 40 | Paolo | VAMOS | Nokia Siemens Networks, China Mobile | juergen.hofmann@nsn.com, liuxiaoyu@chinamobile.com |  |  |  |
| 6525 | 2104.3 | VAMOS Radio Performance Requirements |  | 651d? | 2008-11-24 A | 2011-05-20 A | 100% | 2008-11-24 | 2011-05-20 | 651d? | finish no earlier than 2011-05-20 | GP; G1; G2 | 15624h | 15624h | 22 | Rel-9 | 40 | Paolo | VAMOS | Nokia Siemens Networks, China Mobile | juergen.hofmann@nsn.com, liuxiaoyu@chinamobile.com |  |  |  |
| 6526 | 2104.4 | VAMOS - MS conformance testing |  | 392d? | 2010-09-03 A | 2012-03-02 A | 100% | 2010-09-03 | 2012-03-02 | 392d? | finish no earlier than 2012-03-02 | G3new | 3128h | 3128h | 25 | Rel-9 | 47 | Ingbert | VAMOS_MStest | BlackBerry | Raveendra Seetharam (rseetharam@rim.com) |  | VAMOS_MStest |  |
| 6527 | 2104.5 | VAMOS - BTS conformance testing |  | 201d? | 2010-11-26 A | 2011-09-02 A | 100% | 2010-11-26 | 2011-09-02 | 201d? | finish no earlier than 2011-09-02 | G1 | 1608h | 1608h | 26 | Rel-9 | 48 | Paolo | VAMOS_BTStest | Nokia Siemens Networks | eddie.riddington@nsn.com |  | VAMOS_BTStest |  |

Notes:
- 6504: RP#47 completed / Impacted TSs and TRs: UTRA
- 6505: RP#47 completed / Impacted TSs and TRs: 25.101; 25.104; 25.133; 25.211; 25.212; 25.213; 25.214; 25.215; 25.319; 25.306; 25.321; 25.331; 25.423; 25.433
- 6506: RP#46 completed. RP#62 existing TS 25.317 replaced by new TS 25.327 / Impacted TSs and TRs: 25.101; 25.104; 25.133; 25.306; 25.308; 25.331; 25.423; 25.433; new 25.317 replaced by new 25.327
- 6507: RP#46 completed / Impacted TSs and TRs: 25.101; 25.104; 25.133; 25.211; 25.212; 25.213; 25.214; 25.215; 25.308; 25.321; 25.331; 26.306; 25.423; 25.433
- 6508: RP#46 completed / Impacted TSs and TRs: 25.101; 25.104; 25.211; 25.212; 25.213; 25.214; 25.215; 25.308; 25.306; 25.321; 25.331; 25.423; 25.433
- 6509: RP#46 completed / Impacted TSs and TRs: 25.102; 25.105; 25.123; 25.225; 25.423; 25.433
- 6510: -
- 6511: UTRA. RP#52 completed. Testing for Rel-9 UID_430016 Combination of DC-HSDPA with MIMO / Impacted TSs and TRs: UTRA 34.108; 34.121-1; 34.121-2; 34.123-1; 34.123-2; 34.123-3
- 6512: RP#58 completed. Testing for Rel-9 UID_430014 Dual-Cell HSUPA / Impacted TSs and TRs: UTRA 34.108; 34.121-1; 34.121-2; 34.123-1; 34.123-2; 34.123-3
- 6513: RP#55 completed. Testing for Rel-9 UID_430015 Support for different bands for Dual-Cell HSDPA / Impacted TSs and TRs: UTRA 34.108; 34.121-1; 34.121-2; 34.123-1; 34.123-2; 34.123-3
- 6514: - / Impacted TSs and TRs: LTE
- 6515: RP#46 completed / Impacted TSs and TRs: 36.104; 36.141; new 36.931
- 6516: RP#47 completed / Impacted TSs and TRs: 36.101; 36.211; 36.212; 36.213; 36.331
- 6517: RP#52 completed. Testing for UID_430029 (Enhanced Dual-Layer transmission for LTE) / Impacted TSs and TRs: 36.508; 36.521-1; 36.521-2
- 6518: RP#47 completed / Impacted TSs and TRs: LTE 25.413; 36.300; 36.413; 36.423; 48.018; New 36.902
- 6519: GP#46 still ongoing MS testing. Linked to Rel-10 RAN4 UID_450027 (AGNSS Minimum Performance for UTRAN)
- 6520: GP#45 completed (open performance requirements alignment GPS/Galileo) / Impacted TSs and TRs: 45.005
- 6521: GP#50 completed / Impacted TSs and TRs: 51.010-1; new 51.010-7
- 6522: Triggered by UID_50590 (MUROS) Study on Multi-User Reusing-One-Slot
- 6523: GP#46 completed. GP#40 WID approved / Impacted TSs and TRs: 45.001
- 6524: GP#49 completed. GP#40 WID approved / Impacted TSs and TRs: 24.008; 44.018; 45.002; 45.003; 45.004; 45.008; 48.008; 48.058
- 6525: GP#50 completed. GP#40 WID approved / Impacted TSs and TRs: 45.005
- 6526: GP#53 completed. GP#47 WID approved / Impacted TSs and TRs: 51.010-1; 51.010-2
- 6527: GP#51 completed. GP#48 WID approved / Impacted TSs and TRs: 51.021

| ID | WBS | Task | Type | Duration | Start | Finish | Complete | Baseline start | Baseline finish | Baseline duration | Constraint | Resources | Work | Actual work | Acronym | PCG approved | WI rapporteur name | WI rapporteur e-mail | Release | TSG approved | MCC resp | Acronym_3GU_Export | PCG stopped | TSG stopped | Special Focus Doc | Status Report |
| --- | --- | --- | --- | --- | --- | --- | --- | --- | --- | --- | --- | --- | --- | --- | --- | --- | --- | --- | --- | --- | --- | --- | --- | --- | --- | --- |
| 6528 | 2105 | **Cell Broadcast protocol Base Station Controller – Cell Broadcast Centre (BSC-CBC)** |  | 222d? | 2009-05-15 A | 2010-03-19 A | 100% | 2009-05-15 | 2010-03-19 | 222d? |  | GP; C1 | 7024h | 7024h | CEBRO | 23 | Ericsson | claes-goran.persson@ericsson.com | Rel-9 | 42 | Paolo | CEBRO |  |  |  |  |
| 6529 | 2105.1 | GERAN part of Cell Broadcast protocol Base Station Controller – Cell Broadcast Centre |  | 212d? | 2009-05-15 A | 2010-03-05 A | 100% | 2009-05-15 | 2010-03-05 | 212d? | finish no earlier than 2010-03-05 | GP | 1696h | 1696h | CEBRO | 23 | Ericsson | claes-goran.persson@ericsson.com | Rel-9 | 42 | Paolo |  |  |  |  |  |
| 6530 | 2105.2 | CT1 part of Cell Broadcast protocol Base Station Controller – Cell Broadcast Centre |  | 222d? | 2009-05-15 A | 2010-03-19 A | 100% | 2009-05-15 | 2010-03-19 | 222d? | finish no earlier than 2010-03-19 | C1 | 1776h | 1776h | CEBRO | 23 | Ericsson | claes-goran.persson@ericsson.com | Rel-9 | 42 | Frederic |  |  |  |  |  |
| 6531 | 2106 | Hybrid Location |  | 136d? | 2009-05-18 A | 2009-11-20 A | 100% | 2009-05-18 | 2009-11-20 | 136d? | finish no earlier than 2009-11-20 | GP | 1088h | 1088h | HILT | 23 | TruePosition | Matt Ward (mward@trueposition.com) | Rel-9 | 42 | Paolo | HILT |  |  |  |  |
| 6532 | 2107 | (Small) Technical Enhancements and Improvements for Rel-9 |  | 325d? | 2008-09-15 A | 2009-12-10 A | 100% | 2008-09-15 | 2009-12-10 | 325d? | finish no earlier than 2009-12-10 | SP; CP; RP; GP | 10400h | 10400h | TEI9 | 22 |  |  | Rel-9 | 42 | All | TEI9 |  |  |  |  |
| 6533 | 2108 | Test - (Small) Technical Enhancements and Improvements for Rel-9 |  | 286d? | 2009-11-20 A | 2010-12-24 A | 100% | 2009-11-20 | 2010-12-24 | 286d? | finish no earlier than 2010-12-24 | R5; G3new | 4576h | 4576h | TEI9_Test | 24 |  |  | Rel-9 | 44 | Ingbert | TEI9_Test |  |  |  |  |
| 6534 | 2109 | **Deleted - Services Alignment and Migration** |  | 467d? | 2006-12-06 A | 2008-09-18 A | 100% | 2006-12-06 | 2008-09-18 | 467d? |  | S1 | 7472h | 7472h | ServAl | 17 | Telefónica O2 | chris.friel@O2.com | Rel-9 | 33 | Alain | ServAl | PCG-21 | SP-41 |  |  |
| 6535 | 2109.1 | Deleted - Stage 1 for ServAl |  | 467d? | 2006-12-06 A | 2008-09-18 A | 100% | 2006-12-06 | 2008-09-18 | 467d? | finish no earlier than 2008-12-11 | S1 | 3736h | 3736h |  | 21 | Telefónica O2 | chris.friel@O2.com | Rel-9 | 33 | Alain |  | PCG-21 | SP-41 |  |  |
| 6536 | 2110 | Deleted - Harmonization of Gq'/Rx for Common IMS |  | 304d? | 2008-01-14 A | 2009-03-12 A | 100% | 2008-01-14 | 2009-03-12 | 304d? | finish no earlier than 2009-03-12 | S2 | 2432h | 2432h | IMS_Comm_GqRx_Harm | 21 | Alcatel-Lucent | geoffrey.cristallo@alcatel-lucent.be | Rel-9 | 38 | Maurice | IMS_Comm_GqRx_Harm | PCG-22 | SP-43 |  |  |
| 6537 | 2111 | Deleted - Support of WiMAX - LTE Mobility |  | 407d? | 2008-06-06 A | 2009-12-25 A | 100% | 2008-06-06 | 2009-12-25 | 407d? | start no earlier than 2008-06-06 | R2 | 3248h | 3248h | WiMAX_LTE_Mobility | 21 | Samsung |  | Rel-9 | 38 | Yong-Jun | WiMAX_LTE_Mobility | PCG-21 | SP-39 |  |  |
| 6538 | 2112 | Deleted - Support of WiMAX - UMTS Mobility |  | 407d? | 2008-06-06 A | 2009-12-25 A | 100% | 2008-06-06 | 2009-12-25 | 407d? | start no earlier than 2008-06-06 | R2 | 3248h | 3248h | WiMAX_UMTS_Mobility | 21 | Intel |  | Rel-9 | 38 | Yong-Jun | WiMAX_UMTS_Mobility | PCG-21 | SP-39 |  |  |
| 6539 | 2113 | Deleted - Definition of 3GPP UICC services over the new high-speed interface | milestone | 0d? | 2010-03-19 A | 2010-03-19 A | 100% | 2010-03-19 | 2010-03-19 | 0d? |  | C6 |  |  | UICCHS | 21 | Gemalto | Denis.Lheriteau@gemalto.com | Rel-9 | 38 | Xavier | UICCHS | PCG-24 | CP-47 |  |  |
| 6540 | 2114 | **Deleted - SAES Enhancements (non RAN aspects)** |  | 381d? | 2007-06-25 A | 2008-12-08 A | 100% | 2007-06-25 | 2008-12-08 | 381d? |  | S2 | 11664h | 11664h | SAES_Ph2 | 20 | Nokia Siemens Networks |  | Rel-9 | 39 | Maurice | SAES_Ph2 | PCG-21 | SP-39 |  |  |
| 6541 | 2114.1 | Deleted - Functions and procedures for SAE to support LTE MBMS |  | 381d? | 2007-06-25 A | 2008-12-08 A | 100% | 2007-06-25 | 2008-12-08 | 381d? | finish no earlier than 2008-12-08 | S2 | 3048h | 3048h | SAES_Ph2 | 18 |  |  | Rel-9 | 35 | Maurice |  | PCG-21 | SP-39 |  |  |
| 6542 | 2114.2 | Deleted - CS over EPS |  | 194d? | 2008-03-12 A | 2008-12-08 A | 100% | 2008-03-12 | 2008-12-08 | 194d? | finish no earlier than 2008-12-08 | S2 | 1552h | 1552h | SAES_Ph2 | 21 |  |  | Rel-9 | 39 | Maurice |  | PCG-21 | SP-39 |  |  |
| 6543 | 2114.3 | **Deleted - SAE for generic support for non-3GPP accesses** |  | 251d? | 2007-06-25 A | 2008-06-09 A | 100% | 2007-06-25 | 2008-06-09 | 251d? |  | S2 | 4016h | 4016h | SAES_Ph2 | 21 |  |  | Rel-9 | 39 | Maurice |  | PCG-21 | SP-39 |  |  |
| 6544 | 2114.3.1 | Deleted - Single Radio Aspects of SAE for Optimized Handover with WiMAX |  | 251d? | 2007-06-25 A | 2008-06-09 A | 100% | 2007-06-25 | 2008-06-09 | 251d? | finish no earlier than 2008-06-09 | S2 | 2008h | 2008h | SAES_Ph2 | 21 |  |  | Rel-9 | 39 | Maurice |  | PCG-21 | SP-39 |  |  |
| 6545 | 2115 | Deleted - Lawful Interception in the 3GPP Rel-9 |  | 211d? | 2009-06-04 A | 2010-03-25 A | 100% | 2009-06-04 | 2010-03-25 | 211d? | finish no earlier than 2010-03-25 | S3 | 1688h | 1688h | LI9 | 23 | PIDS, Nortel | Koen Jaspers, Ronald Ryan | Rel-9 | 44 | Mirko | LI9 | PCG-24 | SP-47 |  |  |
| 6546 | 2116 | Release 9 Studies | milestone | 0d? | 2008-06-05 A | 2008-06-05 A | 100% | 2008-06-05 | 2010-03-19 | 468d? |  | CP; RP; SP |  |  |  |  |  |  | Rel-9 |  |  |  |  |  |  |  |
| 6547 | 2117 | Study on Service Specific Access Control in EPS |  | 136d? | 2008-06-05 A | 2008-12-11 A | 100% | 2008-06-05 | 2008-12-11 | 136d? | start no earlier than 2008-06-05 | S1 | 1088h | 1088h | FS_SSAC | 21 | NTT DoCoMo | Shin-ichi Isobe (isobes@nttdocomo.co.jp) | Rel-9 | 40 | Alain | FS_SSAC |  |  |  |  |
| 6548 | 2118 | Study on CS Domain Services over EPS access |  | 492d? | 2007-04-25 A | 2009-03-12 A | 100% | 2007-04-25 | 2009-03-12 | 492d? | finish no earlier than 2009-03-12 | S2 | 3936h | 3936h | FS_CSoPS | 18 | T-Mobile | Karl-Heinz.Nenner@T-Mobile.net | Rel-9 | 35 | Maurice | FS_CSoPS |  |  |  |  |
| 6549 | 2119 | Study on Extended Support of IMS Emergency Calls |  | 319d? | 2007-09-24 A | 2008-12-11 A | 100% | 2007-09-24 | 2008-12-11 | 319d? | finish no earlier than 2009-06-18 | S2 | 2552h | 2552h | FS_IMS-eCall | 19 | Qualcomm | Stephen Edge | Rel-9 | 37 | Maurice | FS_IMS-eCall |  |  | Public Safety (I-A) |  |
| 6550 | 2120 | Study on Service Continuity for Emergency Voice Calls |  | 721d? | 2006-06-08 A | 2009-03-12 A | 100% | 2006-06-08 | 2009-03-12 | 721d? | finish no earlier than 2009-03-12 | S2 | 5768h | 5768h | FS_VCCEm | 17 | Nortel | Ricky Kaura (rkaura@nortel.com) | Rel-9 | 32 | Maurice | FS_VCCEm |  |  | Public Safety (I-A) |  |
| 6551 | 2121 | Study on Security Aspects of Remote Provisioning and Change of Subscription for M2M Equipment |  | 1483.15d? | 2004-04-06 A | 2009-12-10 A | 100% | 2004-04-06 | 2009-12-10 | 1483.15d? | finish no earlier than 2009-12-10 | S3; C6 | 23730.4h | 23730.4h | FS_UM2M | 19 | Ericsson | vesa.lehtovirta@ericsson.com | Rel-9 | 37 | Mirko | FS_UM2M |  |  | MTC, M2M |  |
| 6552 | 2122 | Study on System Maintenance over Itf-N |  | 602d? | 2007-06-07 A | 2009-09-24 A | 100% | 2007-06-07 | 2009-09-24 | 602d? | finish no earlier than 2009-09-24 | S5 | 4808h | 4808h | FS_OAM-Maint-Itf-N | 19 | ZTE | Shuqiang Huang (huangsq@zte.com.cn) | Rel-9 | 36 | Mirko | FS_OAM-Maint-Itf-N |  |  |  |  |
| 6553 | 2123 | Study on Self-Organizing Networks (SON) related OAM interfaces for Home NodeB |  | 522d? | 2007-06-07 A | 2009-06-04 A | 100% | 2007-06-07 | 2009-06-04 | 522d? | finish no earlier than 2009-12-10 | S5 | 4168h | 4168h | FS_OAM-SON-HNB | 19 | Huawei | Zou Lan (zlan@huawei.com) | Rel-9 | 36 | Mirko | FS_OAM-SON-HNB |  |  | HNB, SON |  |
| 6554 | 2124 | Study on Self-healing of Self-Organizing Networks (SON) |  | 416d? | 2008-02-22 A | 2009-09-24 A | 100% | 2008-02-22 | 2009-09-24 | 416d? | finish no earlier than 2009-09-24 | S5 | 3320.15h | 3320.15h | FS_OAM-SON-SH | 21 | ZTE | zhu.weihong@zte.com.cn | Rel-9 | 39 | Mirko | FS_OAM-SON-SH |  |  | SON |  |
| 6555 | 2125 | Study on Service Oriented Architecture (SOA) for IRP |  | 262d? | 2008-06-05 A | 2009-06-04 A | 100% | 2008-06-05 | 2009-06-04 | 262d? | finish no earlier than 2009-05-20 | S5 | 2088h | 2088h | FS_OAM_SOA_IRP | 21 | Ericsson | edwin.tse@ericsson.com | Rel-9 | 40 | Mirko | FS_OAM_SOA_IRP |  |  |  |  |
| 6556 | 2126 | Study on Evaluation of the inclusion of Path Loss Based Technology in the UTRAN |  | 516d? | 2007-12-17 A | 2009-12-04 A | 100% | 2007-12-17 | 2009-12-04 | 516d? | finish no earlier than 2009-09-18 | R4 | 4120h | 4120h | FS_RAN-Pathloss | 21 | Polaris Wireless | Norman Shaw (nshaw@polariswireless.com) | Rel-9 | 38 | Issam | FS_RAN-Pathloss |  |  |  | RP-091080 |
| 6557 | 2127 | Study on LTE-Advanced |  | 522d? | 2008-03-21 A | 2010-03-19 A | 100% | 2007-03-23 | 2010-03-19 | 781.2d? | finish no earlier than 2010-03-19 | R1; R2; R3; R4 | 16704h | 16704h | FS_RAN_LTEA | 21 | NTT DoCoMo | Tetsushi Abe | Rel-9 | 39 | Patrick | FS_RAN_LTEA |  |  | CA | RP-100080 |
| 6558 | 2128 | Study on 1.28 Mcps TDD Home NodeB |  | 387d? | 2008-02-20 A | 2009-12-04 A | 100% | 2008-02-20 | 2009-12-04 | 387d? | finish no earlier than 2009-12-04 | R4 | 3096h | 3096h | FS_RAN-HNBLCRTDD | 21 | TD Tech | Li Rong (lirong@td-tech.com) | Rel-9 | 41 | Issam | FS_RAN-HNBLCRTDD |  |  | HNB | RP-091081 |
| 6559 | 2129 | Study on E-UTRAN Mobility Evaluation and Enhancement |  | 126d? | 2008-12-05 A | 2009-05-29 A | 100% | 2008-12-05 | 2009-05-29 | 126d? | finish no earlier than 2009-05-29 | R1 | 1008h | 1008h | FS_EUTRAN_mob | 22 | Qualcomm | Rajat Prakash (rprakash@qualcomm.com) | Rel-9 | 42 | Patrick | FS_EUTRAN_mob |  |  |  | RP-090426 |
| 6560 | 2130 | Study on Minimization of drive-tests in Next Generation Networks |  | 196d? | 2009-03-06 A | 2009-12-04 A | 100% | 2009-03-06 | 2009-12-04 | 196d? | finish no earlier than 2009-12-04 | R2 | 1568h | 1568h | FS_NGN_min_drive-tests | 22 | Qualcomm | Masato Kitazoe (mkitazoe@qualcomm.com) | Rel-9 | 43 | Yong-Jun | FS_NGN_min_drive-tests |  |  |  | RP-091084 |
| 6561 | 2131 | Study on Enhanced Interference Management for HNBs |  | 61d? | 2009-03-06 A | 2009-05-29 A | 100% | 2009-03-06 | 2009-05-29 | 61d? | start no earlier than 2009-03-06 | R4 | 488h | 488h | FS_eInterfMgmt_HNB | 22 | Qualcomm | Farhad Meshkati (fmeshkat@qualcomm.com) | Rel-9 | 43 | Issam | FS_eInterfMgmt_HNB |  |  | HNB | RP-090429 |
| 6562 | 2132 | Study on Enhanced Interference Management Mechanisms for HNBs |  | 81d? | 2009-05-30 A | 2009-09-18 A | 100% | 2009-05-30 | 2009-09-18 | 81d? | finish no earlier than 2009-09-18 | R3 | 648h | 648h | FS_eInterfMgmtMchsm_HNB | 23 | Qualcomm | Farhad Meshkati (fmeshkat@qualcomm.com) | Rel-9 | 44 | Juha | FS_eInterfMgmtMchsm_HNB |  |  | HNB | RP-090733 |
| 6563 | 2133 | Deleted - Study on Protection against SMS and MMS spam |  | 862d? | 2006-06-08 A | 2009-09-24 A | 100% | 2006-06-08 | 2009-09-24 | 862d? | finish no earlier than 2009-09-24 | S3 | 6896h | 6896h | FS_CPSMal | 17 | Orange | eric.gauthier@orange.ch | Rel-9 | 32 | Mirko | FS_CPSMal | PCG-23 | SP-45 |  |  |
| 6564 | 2134 | --- RELEASE 8 --- |  | 914.3d? | 2006-09-19 A | 2010-03-19 A | 100% | 2006-09-19 | 2010-03-19 | 914.3d? | start no earlier than 2000-01-03 | CP; GP; RP; SP | 29257.6h | 29257.6h |  |  |  |  | Rel-8 |  |  |  |  |  |  |  |

Notes:
- 6528: CP#47 completed. GP#45 completed. GP#42 WID approved
- 6529: GP#45 completed. GP#42 WID approved / Impacted TSs and TRs: new 48.049
- 6530: CP#47 completed / Impacted TSs and TRs: 23.041
- 6531: GP#44 completed. GP#42 WID approved (Hybrid Integrated Location Technology=HILT) / Impacted TSs and TRs: 43.059; 48.071
- 6532: SP#46 completed
- 6533: GP#44 created
- 6534: SP#41 closed (no tangible result of this work¦no CR against TR 22.983). Triggered by Study UID_370086 (FSServAl)
- 6535: SP#41 closed (no tangible result of this work¦no CR against TR 22.983) / Impacted TSs and TRs: 22.983
- 6536: SP#43 stopped. LS_out to TISPAN informs about stopping this activity / Impacted TSs and TRs: 23.822; 23.203
- 6537: RP#39: No agreed WID / Impacted TSs and TRs: 36.306; 36.331; 36.413; 36.300; 36.214; 36.133; 36.304
- 6538: RP#39: No agreed WID / Impacted TSs and TRs: 25.306; 25.331; 25.413
- 6539: CP#47 work stopped/abandoned / Impacted TSs and TRs: 31.xyz
- 6540: SP#39 created to host Rel-9 Wis. BUT no agreed WID
- 6541: SP#39 SAE functionality moved to Rel-9. WID returned to SA2 for re-consideration & remove MBMS for EPS from Rel 8
- 6542: SP#39 SAE functionality moved to Rel-9. BUT no agreed WID
- 6543: SP#39 SAE functionality moved to Rel-9. BUT no agreed WID
- 6544: SP#39 SAE functionality moved to Rel-9. BUT no agreed WID
- 6545: SP#47 stopped. WI + new topics moved to Rel-10 / Impacted TSs and TRs: 33.106; 33.107; 33.108
- 6546: -
- 6547: SP#42 completed. Spin-off Feature UID_420020 (SSAC) / Impacted TSs and TRs: 22.986
- 6548: SP#43 completed. Linked to Combinational Services UID_31064, Services Alignment and Migration (ServAl) UID_330017 and 3GPP System Architecture Evolution (SAES) UID_3208 / Impacted TSs and TRs: 23.879
- 6549: SP#42 completed / Impacted TSs and TRs: 23.868
- 6550: SP#43 completed / Impacted TSs and TRs: 23.826
- 6551: SP#46 completed. Triggered by the SA1 Rel-8 Study on Facilitating Machine to Machine Communication in GSM and UMTS (FS_M2M) UID_7027 in TR 22.868. / Impacted TSs and TRs: 33.812
- 6552: SP#45 completed / Impacted TSs and TRs: 32.822
- 6553: SP#44 completed. Linked to SA5 TR 32.816 Study of Management for LTE and SAE (UID_340036) / Impacted TSs and TRs: 32.821
- 6554: SP#45 completed. Linked to SA5 TR 32.816 Study of Management for LTE and SAE (UID_340036) / Impacted TSs and TRs: 32.823
- 6555: SP#44 completed. Spin-off implementation WI UID_440064 Service Oriented Architecture (SOA) for IRP / Impacted TSs and TRs: 32.824
- 6556: RP#46 completed / Impacted TSs and TRs: 25.907
- 6557: RP#47 completed / Impacted TSs and TRs: 36.913 ; New 36.814; 36.912; R2 36.806 (Relay architectures for E-UTRA); R4 36.815 (LTE-Advanced feasibility studies in RAN4)
- 6558: RP#46 completed / Impacted TSs and TRs: 25.866
- 6559: RP#44 closed (RP-090452 R1 LS to RAN on Conclusions for LTE Mobility Study Item - no further Rel-9 action / no TR needed) / Impacted TSs and TRs: none
- 6560: RP#46 completed / Impacted TSs and TRs: 36.805
- 6561: RP#44 completed. Linked to UID_420008 LTE FDD Home eNodeB RF Requirements. Spin-off RAN3 UID_440015 Study on Enhanced Interference Management Mechanisms for HNBs / Impacted TSs and TRs: 25.967
- 6562: RP#45 completed. Triggered by RAN4 UID_430027 Study on Enhanced Interference Management for HNBs / Impacted TSs and TRs: 25.967
- 6563: SP#45 work stopped/abandoned / Impacted TSs and TRs: 33.9xx
- 6564: -

| ID | WBS | Task | Duration | Start | Finish | Complete | Baseline start | Baseline finish | Baseline duration | Constraint | Resources | Work | Actual work | Acronym | PCG approved | WI rapporteur name | WI rapporteur e-mail | Release | TSG approved | MCC resp | Acronym_3GU_Export |
| --- | --- | --- | --- | --- | --- | --- | --- | --- | --- | --- | --- | --- | --- | --- | --- | --- | --- | --- | --- | --- | --- |
| 6565 | 2135 | **3GPP System Architecture Evolution Specification - Evolved Packet System (non RAN aspects)** | 1618d? | 2006-04-12 A | 2012-06-15 A | 100% | 2006-04-12 | 2012-06-15 | 1618d? |  | S1; S2; S3; S5; C1; C3; C4; C6; IETF | 510115h | 510115h | SAES | 17 | T-Mobile | michael.kurz@t-mobile.at | Rel-8 | 32 | Alain | SAES |
| 6566 | 2135.1 | Requirements for evolution of the 3GPP system architecture | 395d? | 2006-06-08 A | 2007-12-12 A | 100% | 2006-06-08 | 2007-12-12 | 395d? | finish no earlier than 2007-11-30 | S1 | 3160h | 3160h | AIPN-SAE | 17 | T-Mobile | michael.kurz@t-mobile.at | Rel-8 | 32 | Alain | AIPN-SAE |
| 6567 | 2135.2 | **High level and common (for all accesses) functions** | 629d? | 2007-01-02 A | 2009-05-29 A | 100% | 2007-01-02 | 2009-05-29 | 629d? |  | S2; S3; C1; C3; C4 | 62664h | 62664h | EPS-ComF | 19 | Nokia Siemens Networks | balazs.bertenyi@nsn.com | Rel-8 | 37 | Maurice | EPS-ComF |
| 6568 | 2135.2.1 | Stage 2 for High level functions | 370d? | 2007-01-02 A | 2008-06-02 A | 100% | 2007-01-02 | 2008-06-02 | 370d? | finish no earlier than 2008-06-02 | S2 | 2960h | 2960h | SAES-SA-HLF | 18 | Motorola | Irfan.Ali@motorola.com | Rel-8 | 35 | Maurice | SAES-SA-HLF |
| 6569 | 2135.2.2 | Stage 2 Security Architecture | 197d? | 2008-03-12 A | 2008-12-11 A | 100% | 2008-03-12 | 2008-12-11 | 197d? | finish no earlier than 2008-12-11 | S3 | 1576h | 1576h | SAES | 21 | Nokia Siemens Networks | marc.blommaert.ext@nsn.com | Rel-8 | 39 | Mirko |  |
| 6570 | 2135.2.3 | Stage 3 (CT1) for SAE impact on services, network functions and capabilities | 545d? | 2007-02-05 A | 2009-03-06 A | 100% | 2007-02-05 | 2009-03-06 | 545d? | finish no earlier than 2009-03-06 | C1 | 4360h | 4360h | SAES | 18 | Nokia Siemens Networks | robert.zaus@nsn.com | Rel-8 | 34 | Frederic |  |
| 6571 | 2135.2.4 | Stage 3 SAE impact on existing capabilities | 480d? | 2007-02-05 A | 2008-12-05 A | 100% | 2007-02-05 | 2008-12-05 | 480d? | finish no earlier than 2008-12-12 | C3 | 3840h | 3840h | SAES | 18 | Huawei | Wei Weihua (weiwh@huawei.com) | Rel-8 | 34 | Adrian |  |
| 6572 | 2135.2.5 | Stage 3 (CT4) of SAE impact on existing capabilities | 545d? | 2007-02-05 A | 2009-03-06 A | 100% | 2007-02-05 | 2009-03-06 | 545d? | finish no earlier than 2009-03-06 | C4 | 4360h | 4360h | SAES | 18 | Huawei | shahab.lavasani@huawei.com | Rel-8 | 34 | Kimmo |  |
| 6573 | 2135.2.6 | Stage 2/3 for Network selection procedures | 480d? | 2007-02-05 A | 2008-12-05 A | 100% | 2007-02-05 | 2008-12-05 | 480d? | finish no earlier than 2009-03-06 | C1 | 3840h | 3840h | SAES | 18 | Nokia Siemens Networks | robert.zaus@nsn.com | Rel-8 | 34 | Frederic |  |
| 6574 | 2135.2.7 | Stage 3 EPC interworking with external PDNs (SGi) | 605d? | 2007-02-05 A | 2009-05-29 A | 100% | 2007-02-05 | 2009-05-29 | 605d? | finish no earlier than 2009-05-29 | C3 | 4840h | 4840h | SAES-St3-intwk | 18 | Huawei | Wei Weihua (weiwh@huawei.com) | Rel-8 | 34 | Adrian | SAES-St3-intwk |
| 6575 | 2135.2.8 | Stage 3 PCC within SAE | 605d? | 2007-02-05 A | 2009-05-29 A | 100% | 2007-02-05 | 2009-05-29 | 605d? | finish no earlier than 2009-05-29 | C3 | 4840h | 4840h | SAES-St3-PCC | 18 | Ericsson | j.javier.pastor@ericsson.com | Rel-8 | 34 | Adrian | SAES-St3-PCC |
| 6576 | 2135.2.9 | Stage 3 for SAE / LTE identities | 545d? | 2007-02-05 A | 2009-03-06 A | 100% | 2007-02-05 | 2009-03-06 | 545d? | finish no earlier than 2009-03-06 | C4 | 4360h | 4360h | SAES | 18 | Huawei | shahab.lavasani@huawei.com | Rel-8 | 34 | Kimmo |  |
| 6577 | 2135.2.10 | Unified guidelines for Diameter usage within 3GPP | 316d? | 2007-09-21 A | 2008-12-05 A | 100% | 2007-09-21 | 2008-12-05 | 316d? | finish no earlier than 2008-12-05 | C3 | 2528h | 2528h | SAES-DIAM | 19 | Huawei | Javier Gonzalez Gallego | Rel-8 | 37 | Adrian | SAES-DIAM |
| 6578 | 2135.3 | **SAE for LTE access** | 569d? | 2007-01-02 A | 2009-03-06 A | 100% | 2007-01-02 | 2009-03-06 | 569d? |  | S2; C1; C3; C4 | 80584h | 80584h | SAES-LTE | 18 | Motorola | Irfan.Ali@motorola.com | Rel-8 | 35 | Maurice | SAES-LTE |
| 6579 | 2135.3.1 | CT4 Stage 3 for protocol between EPCs | 545d? | 2007-02-05 A | 2009-03-06 A | 100% | 2007-02-05 | 2009-03-06 | 545d? | finish no earlier than 2009-03-06 | C4 | 4360h | 4360h | SAES-LTE | 18 | Huawei | shahab.lavasani@huawei.com | Rel-8 | 34 | Kimmo |  |
| 6580 | 7.2.2.1 | **SAES-SA-FP_LTE with GTP variant** | 569d? | 2007-01-02 A | 2009-03-06 A | 100% | 2007-01-02 | 2009-03-06 | 569d? |  | S2; C4 | 16448h | 16448h | SAES-SA-FP_LTE-GTP | 18 | Nokia Siemens Networks | balazs.bertenyi@nsn.com | Rel-8 | 35 | Maurice | SAES-SA-FP_LTE-GTP |
| 6581 | 2135.3.2.1 | Stage 2 for SAES-SA-FP_LTE with GTP variant | 373d? | 2007-01-02 A | 2008-06-05 A | 100% | 2007-01-02 | 2008-06-05 | 373d? | finish no earlier than 2008-06-02 | S2 | 2984h | 2984h | SAES-SA-FP_LTE-GTP-St2 | 19 | Nokia Siemens Networks | balazs.bertenyi@nsn.com | Rel-8 | 37 | Maurice | SAES-SA-FP_LTE-GTP-St2 |
| 6582 | 2135.3.2.2 | CT4 Stage 3 for GTP v2 protocol | 545d? | 2007-02-05 A | 2009-03-06 A | 100% | 2007-02-05 | 2009-03-06 | 545d? | finish no earlier than 2009-03-06 | C4 | 4360h | 4360h | SAES-SA-FP_LTE-GTP | 18 | Huawei | shahab.lavasani@huawei.com | Rel-8 | 34 | Kimmo | SAES-SA-FP_LTE-GTP |
| 6583 | 7.2.2.2 | **SAES-SA-FP_LTE with PMIP variant** | 569d? | 2007-01-02 A | 2009-03-06 A | 100% | 2007-01-02 | 2009-03-06 | 569d? |  | S2; C4 | 20288h | 20288h | SAES-SA-FP_LTE-IETF | 18 | Nokia Siemens Networks | balazs.bertenyi@nsn.com | Rel-8 | 35 | Maurice | SAES-SA-FP_LTE-IETF |
| 6584 | 2135.3.3.1 | Stage 2 for SAES-SA-FP_LTE with PMIP variant | 373d? | 2007-01-02 A | 2008-06-05 A | 100% | 2007-01-02 | 2008-06-05 | 373d? | finish no earlier than 2008-06-02 | S2 | 2984h | 2984h | SAES-SA-FP_LTE-IETF-St2 | 19 | Nokia Siemens Networks | balazs.bertenyi@nsn.com | Rel-8 | 37 | Maurice | SAES-SA-FP_LTE-IETF-St2 |
| 6585 | 2135.3.3.2 | CT4 Stage 3 for PMIP protocol within EPC | 545d? | 2007-02-05 A | 2009-03-06 A | 100% | 2007-02-05 | 2009-03-06 | 545d? | finish no earlier than 2009-03-06 | C4 | 4360h | 4360h | SAES-SA-FP_LTE-IETF | 19 | Huawei | shahab.lavasani@huawei.com | Rel-8 | 37 | Kimmo | SAES-SA-FP_LTE-IETF |
| 6586 | 2135.3.3.3 | Mobile IPv4 (MIPv4) based Mobility protocols | 480d? | 2007-02-05 A | 2008-12-05 A | 100% | 2007-02-05 | 2008-12-05 | 480d? | finish no earlier than 2008-12-05 | C4 | 3840h | 3840h | SAES-SA-FP_LTE-IETF | 21 | Motorola | Lewis Milton | Rel-8 | 41 | Kimmo |  |
| 6587 | 2135.3.4 | Stage 3 for UE Non-Access-Stratum (NAS) mobility procedures in idle and active mode | 545d? | 2007-02-05 A | 2009-03-06 A | 100% | 2007-02-05 | 2009-03-06 | 545d? | finish no earlier than 2009-03-06 | C1 | 4360h | 4360h | SAES-LTE | 18 | Nokia Siemens Networks | robert.zaus@nsn.com | Rel-8 | 34 | Frederic |  |
| 6588 | 2135.3.5 | Stage 3 for Session management, bearer control and QoS aspects | 545d? | 2007-02-05 A | 2009-03-06 A | 100% | 2007-02-05 | 2009-03-06 | 545d? | finish no earlier than 2009-03-06 | C1 | 4360h | 4360h | SAES-LTE | 18 | Nokia Siemens Networks | robert.zaus@nsn.com | Rel-8 | 34 | Frederic |  |
| 6589 | 2135.3.6 | Stage 3 for security aspects of LTE Access | 545d? | 2007-02-05 A | 2009-03-06 A | 100% | 2007-02-05 | 2009-03-06 | 545d? | finish no earlier than 2009-03-06 | C1 | 4360h | 4360h | SAES-LTE | 18 | Nokia Siemens Networks | robert.zaus@nsn.com | Rel-8 | 34 | Frederic |  |
| 6590 | 2135.3.7 | Stage 3 for QoS mechanisms | 480d? | 2007-02-05 A | 2008-12-05 A | 100% | 2007-02-05 | 2008-12-05 | 480d? | finish no earlier than 2008-12-12 | C3 | 3840h | 3840h | SAES-LTE | 18 | Ericsson | j.javier.pastor@ericsson.com | Rel-8 | 34 | Adrian |  |
| 6591 | 2135.3.8 | Stage 3 for EPC - HSS interface | 545d? | 2007-02-05 A | 2009-03-06 A | 100% | 2007-02-05 | 2009-03-06 | 545d? | finish no earlier than 2009-03-06 | C4 | 4360h | 4360h | SAES-LTE | 18 | Huawei | shahab.lavasani@huawei.com | Rel-8 | 34 | Kimmo |  |

Notes:
- 6565: Role model for SAE/LTE system wide project management by SA2 in SP-060166
- 6566: SP#38 completed / Impacted TSs and TRs: 22.011; 22.246; New 22.278
- 6567: CP#44 completed
- 6568: SP#40 completed / Impacted TSs and TRs: New 23.402
- 6569: SP#42 completed / Impacted TSs and TRs: 33.210; 33.310; New 33.401
- 6570: CP#43 completed / Impacted TSs and TRs: 24.229; 27.007; New 24.305
- 6571: CP#42 completed / Impacted TSs and TRs: 29.061
- 6572: CP#43 completed / Impacted TSs and TRs: New (29.274; 29.275)
- 6573: CP#42 completed / Impacted TSs and TRs: 23.122; New 24.302
- 6574: CP#44 completed / Impacted TSs and TRs: 29.061
- 6575: CP#44 completed / Impacted TSs and TRs: 29.212; 29.213; 29.214; New 29.215
- 6576: CP#43 completed / Impacted TSs and TRs: 23.003
- 6577: CP#42 completed / Impacted TSs and TRs: New 29.909
- 6578: CP#43 completed
- 6579: CP#43 completed / Impacted TSs and TRs: 29.274; 29.275
- 6580: CP#43 completed
- 6581: SP#40 completed / Impacted TSs and TRs: 23.401; 23.060; 23.002; 23.246; 23.203; 23.107; 23.234; 23.271
- 6582: CP#43 completed / Impacted TSs and TRs: 29.274
- 6583: CP#43 completed
- 6584: SP#40 completed
- 6585: CP#43 completed / Impacted TSs and TRs: 29.275; 29.282
- 6586: CP#42 completed / Impacted TSs and TRs: 29.279
- 6587: CP#43 completed / Impacted TSs and TRs: 24.007; 24.301
- 6588: CP#43 completed / Impacted TSs and TRs: 24.007; 24.301
- 6589: CP#43 completed / Impacted TSs and TRs: 24.008; 24.301
- 6590: CP#42 completed / Impacted TSs and TRs: 29.213
- 6591: CP#43 completed / Impacted TSs and TRs: 29.272

| ID | WBS | Task | Type | Duration | Start | Finish | Complete | Baseline start | Baseline finish | Baseline duration | Constraint | Resources | Work | Actual work | Acronym | PCG approved | WI rapporteur name | WI rapporteur e-mail | Release | TSG approved | MCC resp | Acronym_3GU_Export | Impacted TSs and TRs | TSG stopped |
| --- | --- | --- | --- | --- | --- | --- | --- | --- | --- | --- | --- | --- | --- | --- | --- | --- | --- | --- | --- | --- | --- | --- | --- | --- |
| 6592 | 2135.4 | **SAE for Interoperation between LTE and legacy cellular PS accesses** |  | 545d? | 2007-02-05 A | 2009-03-06 A | 100% | 2007-02-05 | 2009-03-06 | 545d? |  | S2; C1; C4 | 48872h | 48872h | SAES-SA-FP_3GPP | 18 | Motorola | Irfan.Ali@motorola.com | Rel-8 | 35 | Maurice | SAES-SA-FP_3GPP |  |  |
| 6593 | 2135.4.1 | Stage 2 for Interoperation between LTE and 2G/3G |  | 424d? | 2007-02-05 A | 2008-09-18 A | 100% | 2007-02-05 | 2008-09-18 | 424d? | finish no earlier than 2008-09-11 | S2 | 3392h | 3392h | EPSto2_3G | 19 | Motorola | Irfan.Ali@motorola.com | Rel-8 | 37 | Maurice | EPSto2_3G | 23.401; 23.402 |  |
| 6594 | 2135.4.2 | Stage 3 for Inter-system mobility between E-UTRAN and 2G/3G |  | 545d? | 2007-02-05 A | 2009-03-06 A | 100% | 2007-02-05 | 2009-03-06 | 545d? | finish no earlier than 2009-03-06 | C1 | 4360h | 4360h | SAES-SA-FP_3GPP | 21 | Nokia Siemens Networks | robert.zaus@nsn.com | Rel-8 | 38 | Frederic | SAES-SA-FP_3GPP | 24.008; 24.301 |  |
| 6595 | 2135.4.3 | Stage 2 GPRS enhancements for LTE access |  | 272d? | 2007-09-04 A | 2008-09-18 A | 100% | 2007-09-04 | 2008-09-18 | 272d? | start no earlier than 2007-09-04 | S2 | 2176h | 2176h | SAES-GPRS_LTE | 18 | Vodafone | chris.pudney@vodafone.com | Rel-8 | 34 | Maurice | SAES-GPRS_LTE | 23.401 |  |
| 6596 | 2135.4.4 | Stage 2 GPRS for EPC (23.060, etc.) |  | 179d? | 2008-01-14 A | 2008-09-18 A | 100% | 2008-01-14 | 2008-09-18 | 179d? | finish no earlier than 2008-09-18 | S2 | 1432h | 1432h | SAES-SA-FP_3GPP | 21 | Nokia Siemens Networks | balazs.bertenyi@nsn.com | Rel-8 | 39 | Maurice |  | 23.060 |  |
| 6597 | 2135.4.5 | Stage 3 for EPC - GPRS |  | 545d? | 2007-02-05 A | 2009-03-06 A | 100% | 2007-02-05 | 2009-03-06 | 545d? | finish no earlier than 2009-03-06 | C4 | 4360h | 4360h | SAES-SA-FP_3GPP | 18 | Huawei | shahab.lavasani@huawei.com | Rel-8 | 34 | Kimmo |  | 29.274; 29.275; 29.281 |  |
| 6598 | 2135.4.6 | Stage 3 for EPC to UTRAN |  | 545d? | 2007-02-05 A | 2009-03-06 A | 100% | 2007-02-05 | 2009-03-06 | 545d? | finish no earlier than 2009-03-06 | C4 | 4360h | 4360h | SAES-SA-FP_3GPP | 21 | Huawei | shahab.lavasani@huawei.com | Rel-8 | 38 | Kimmo |  | 29.274; 29.275; 29.281 |  |
| 6599 | 2135.4.7 | Stage 3 for EPC to 3GPP2 |  | 545d? | 2007-02-05 A | 2009-03-06 A | 100% | 2007-02-05 | 2009-03-06 | 545d? | finish no earlier than 2009-03-06 | C4 | 4360h | 4360h | SAES-SA-FP_3GPP | 21 | Huawei | shahab.lavasani@huawei.com | Rel-8 | 38 | Kimmo |  | 29.277; 29.276 |  |
| 6600 | 2135.4.8 | Stage 2 for Interoperation between LTE and CDMA2000 |  | 329d? | 2007-06-18 A | 2008-09-18 A | 100% | 2007-06-18 | 2008-09-18 | 329d? | finish no earlier than 2008-04-25 | S2 | 2632h | 2632h | EPStoC2k | 19 | Motorola, Vodafone | Irfan.Ali@motorola.com, chris.pudney@vodafone.com | Rel-8 | 37 | Maurice | EPStoC2k | 23.401; 23.402 |  |
| 6601 | 2135.4.9 | Stage 3 for Inter-system mobility between E-UTRAN and CDMA2000 |  | 545d? | 2007-02-05 A | 2009-03-06 A | 100% | 2007-02-05 | 2009-03-06 | 545d? | finish no earlier than 2009-03-06 | C1 | 4360h | 4360h | SAES-SA-FP_3GPP | 19 | Nokia Siemens Networks | robert.zaus@nsn.com | Rel-8 | 36 | Frederic |  | 24.301; 24.302 |  |
| 6602 | 2135.4.10 | Stage 3 for MME - SGSN signalling free protocol |  | 545d? | 2007-02-05 A | 2009-03-06 A | 100% | 2007-02-05 | 2009-03-06 | 545d? | finish no earlier than 2009-03-06 | C4 | 4360h | 4360h | SAES-SA-FP_3GPP | 18 | Huawei | shahab.lavasani@huawei.com | Rel-8 | 34 | Kimmo |  | 29.272; 29.274 |  |
| 6603 | 2135.5 | **SAE for support for non-3GPP accesses** |  | 1429d? | 2007-01-02 A | 2012-06-15 A | 100% | 2007-01-02 | 2012-06-15 | 1429d? |  | S2; S3; C1; C4; IETF | 123829h | 123829h | SAES-SA-FP_n3GPP | 18 | Motorola | Irfan.Ali@motorola.com | Rel-8 | 35 | Maurice | SAES-SA-FP_n3GPP |  |  |
| 6604 | 7.2.4.1 | Stage 2 for Host-based Mobility aspects |  | 373d? | 2007-01-02 A | 2008-06-05 A | 100% | 2007-01-02 | 2008-06-05 | 373d? | finish no earlier than 2008-04-11 | S2 | 2984h | 2984h | SAES-SA-FP_n3GPP-HBMob | 18 | Motorola | Irfan.Ali@motorola.com | Rel-8 | 35 | Maurice | SAES-SA-FP_n3GPP-HBMob | 23.402 |  |
| 6605 | 7.2.4.2 | Stage 2 for Network-based Mobility aspects |  | 448d? | 2007-01-02 A | 2008-09-18 A | 100% | 2007-01-02 | 2008-09-18 | 448d? | finish no earlier than 2008-09-18 | S2 | 3584h | 3584h | SAES-SA-FP_n3GPP-NBMob | 18 | Motorola | Irfan.Ali@motorola.com | Rel-8 | 35 | Maurice | SAES-SA-FP_n3GPP-NBMob | 23.402 |  |
| 6606 | 2135.5.3 | Stage 3 for Mobility management based on DSMIPv6 |  | 480d? | 2007-02-05 A | 2008-12-05 A | 100% | 2007-02-05 | 2008-12-05 | 480d? | finish no earlier than 2008-12-05 | C1 | 3840h | 3840h | SAES-SA-FP_n3GPP | 19 | Nokia Siemens Networks | robert.zaus@nsn.com | Rel-8 | 36 | Frederic |  | 24.303 |  |
| 6607 | 2135.5.4 | (IETF) Stage 3 for Mobility management based on DSMIPv6 (draft-ietf-mip6-hiopt) |  | 589d? | 2007-02-05 A | 2012-06-15 A | 100% | 2007-02-05 | 2012-06-15 | 589d? | finish no earlier than 2012-09-14 | C1-IETF | 4712h | 4712h | SAES-SA-FP_n3GPP | 27 | Mark Jones |  | Rel-8 | 52 | Frederic |  | RFC 6610 (was draft-ietf-mip6-hiopt); RFC 6610 |  |
| 6608 | 2135.5.5 | (IETF) Stage 3 for Mobility management based on DSMIPv6 (RFC6275) |  | 356d? | 2007-02-05 A | 2011-07-29 A | 100% | 2007-02-05 | 2011-07-29 | 356d? | finish no earlier than 2011-07-29 | C1-IETF | 2848h | 2848h | SAES-SA-FP_n3GPP | 27 |  |  | Rel-8 | 52 | Frederic |  | RFC 6275 (was draft-ietf-mext-rfc3775bis) |  |
| 6609 | 2135.5.6 | Stage 3 for Mobility management based on MIP v4 |  | 480d? | 2007-02-05 A | 2008-12-05 A | 100% | 2007-02-05 | 2008-12-05 | 480d? | start no earlier than 2007-02-05 | C1 | 3840h | 3840h | SAES-SA-FP_n3GPP | 21 | Nokia Siemens Networks | robert.zaus@nsn.com | Rel-8 | 39 | Frederic |  | 24.304 |  |
| 6610 | 2135.5.7 | Stage 3 for Inter-system mobility between E-UTRAN and non 3GPP accesses |  | 545d? | 2007-02-05 A | 2009-03-06 A | 100% | 2007-02-05 | 2009-03-06 | 545d? | finish no earlier than 2009-03-06 | C1 | 4360h | 4360h | SAES-SA-FP_n3GPP | 21 | Nokia Siemens Networks | robert.zaus@nsn.com | Rel-8 | 38 | Frederic |  | 24.008; 24.301 |  |
| 6611 | 2135.5.8 | Stage 2 for Optimized Dual-Radio Handover with WiMAX |  | 249d? | 2007-06-25 A | 2008-06-05 A | 100% | 2007-06-25 | 2008-06-05 | 249d? | finish no earlier than 2008-06-09 | S2 | 1992h | 1992h | SAES-SA-FP_n3GPP-OptWIMAX | 19 | Motorola | Irfan.Ali@motorola.com | Rel-8 | 36 | Maurice | SAES-SA-FP_n3GPP-OptWIMAX | 23.402 |  |
| 6612 | 2135.5.9 | Stage 2 Security aspects for non-3GPP Access |  | 197d? | 2008-03-12 A | 2008-12-11 A | 100% | 2008-03-12 | 2008-12-11 | 197d? | finish no earlier than 2008-12-11 | S3 | 1576h | 1576h | SAES-SA-FP_n3GPP | 21 | Nokia Siemens Networks | marc.blommaert.ext@nsn.com | Rel-8 | 39 | Mirko |  | 33.402; 33.210; 33.310 |  |
| 6613 | 2135.5.10 | Stage 3 security aspects for DSMIPv6 Access |  | 480d? | 2007-02-05 A | 2008-12-05 A | 100% | 2007-02-05 | 2008-12-05 | 480d? | finish no earlier than 2008-12-05 | C1 | 3840h | 3840h | SAES-SA-FP_n3GPP | 19 | Nokia Siemens Networks | robert.zaus@nsn.com | Rel-8 | 37 | Frederic |  | 24.303 |  |
| 6614 | 2135.5.11 | Stage 3 security aspects for MIPv4 Access |  | 480d? | 2007-02-05 A | 2008-12-05 A | 100% | 2007-02-05 | 2008-12-05 | 480d? | finish no earlier than 2008-12-05 | C1 | 3840h | 3840h | SAES-SA-FP_n3GPP | 21 | Nokia Siemens Networks | robert.zaus@nsn.com | Rel-8 | 39 | Frederic |  | 24.304 |  |
| 6615 | 2135.5.12 | Stage 3 for Access to the EPC via non-3GPP access networks |  | 545d? | 2007-02-05 A | 2009-03-06 A | 100% | 2007-02-05 | 2009-03-06 | 545d? | finish no earlier than 2009-03-06 | C1 | 4360h | 4360h | SAES-SA-FP_n3GPP | 19 | Nokia Siemens Networks | robert.zaus@nsn.com | Rel-8 | 36 | Frederic |  | 24.302; 24.312 |  |
| 6616 | 2135.5.13 | Stage 3 for interfaces within EPC |  | 383d? | 2007-09-19 A | 2009-03-06 A | 100% | 2007-09-19 | 2009-03-06 | 383d? | finish no earlier than 2009-03-06 | C4 | 3064h | 3064h | SAES-SA-FP_n3GPP | 19 | Huawei | shahab.lavasani@huawei.com | Rel-8 | 37 | Kimmo |  | 29.274; 29.281 |  |
| 6617 | 2135.5.14 | Stage 3 for Interfaces EPC - non-3GPP IP access |  | 545d? | 2007-02-05 A | 2009-03-06 A | 100% | 2007-02-05 | 2009-03-06 | 545d? | finish no earlier than 2009-03-06 | C4 | 4360h | 4360h | SAES-SA-FP_n3GPP | 18 | Huawei | shahab.lavasani@huawei.com | Rel-8 | 34 | Kimmo |  | 29.273; 29.275 |  |
| 6618 | 2135.5.15 | (IETF) Stage 3 for Interfaces EPC - non-3GPP IP access |  | 1224.6d? | 2007-02-05 A | 2012-06-15 A | 100% | 2007-02-05 | 2012-06-15 | 1224.6d? | finish no earlier than 2012-06-15 | C4-IETF | 9788.8h | 9788.8h | SAES-SA-FP_n3GPP | 27 | Lionel Morand |  | Rel-8 | 52 | Kimmo |  | RFC 6611 (was draft-ietf-mip6-bootstrapping-integrated) |  |
| 6619 | 2135.5.16 | Stage 3 for AAA/HSS related |  | 480d? | 2007-02-05 A | 2008-12-05 A | 100% | 2007-02-05 | 2008-12-05 | 480d? | finish no earlier than 2008-12-05 | C4 | 3840h | 3840h | SAES-SA-FP_n3GPP | 18 | Huawei | shahab.lavasani@huawei.com | Rel-8 | 34 | Kimmo |  | 29.273 |  |
| 6620 | 2135.5.17 | Stage 3 for EPC - AAA interface |  | 480d? | 2007-02-05 A | 2008-12-05 A | 100% | 2007-02-05 | 2008-12-05 | 480d? | finish no earlier than 2008-12-05 | C4 | 3840h | 3840h | SAES-SA-FP_n3GPP | 18 | Huawei | shahab.lavasani@huawei.com | Rel-8 | 34 | Kimmo |  | 29.273 |  |
| 6621 | 2135.5.18 | Deleted (already covered) SAES-SA-FP_n3GPP Optimized Handover with CDMA | milestone | 0d? | 2007-06-25 A | 2007-06-25 A | 100% | 2007-06-25 | 2007-06-25 | 0d? | finish no earlier than 2007-06-25 | S2 |  |  | SAES-SA-FP_n3GPP-OptCDMA | 19 | Nokia Siemens Networks |  | Rel-8 | 36 | Maurice | SAES-SA-FP_n3GPP-OptCDMA |  | SP-37 |

Notes:
- 6592: CP#43 completed
- 6593: SP#41 completed
- 6594: CP#43 completed
- 6595: SP#41 completed
- 6596: SP#41 completed
- 6597: CP#43 completed
- 6598: CP#43 completed
- 6599: CP#43 completed
- 6600: SP#41 completed (except: Handover of multiple PDNs=>Rel-9)
- 6601: CP#43 completed
- 6602: CP#43 completed
- 6603: CP#43 completed. SP#39 retained in Rel-8 (in addition to the essential functionality defined in SP-070699). Replaces UID_340037
- 6604: SP#40 completed
- 6605: SP#41 completed
- 6606: CP#42 completed
- 6607: CP#56 completed; 9/4/21: RFC 6610 added;
- 6608: SP#53/IETF#81 completed
- 6609: CP#42 completed
- 6610: CP#43 completed
- 6611: SP#40 completed
- 6612: SP#42 completed
- 6613: CP#42 completed
- 6614: CP#42 completed
- 6615: CP#43 completed
- 6616: CP#43 completed
- 6617: CP#43 completed
- 6618: CP#56 completed
- 6619: CP#42 completed
- 6620: CP#42 completed
- 6621: SP#37 stopped

| ID | WBS | Task | Type | Duration | Start | Finish | Complete | Baseline start | Baseline finish | Baseline duration | Constraint | Resources | Work | Actual work | Acronym | PCG approved | WI rapporteur name | Release | TSG approved | MCC resp | Acronym_3GU_Export | Impacted TSs and TRs | PCG stopped | TSG stopped | Special Focus Doc |
| --- | --- | --- | --- | --- | --- | --- | --- | --- | --- | --- | --- | --- | --- | --- | --- | --- | --- | --- | --- | --- | --- | --- | --- | --- | --- |
| 6622 | 2135.6 | **Single Radio Voice Call Continuity for 3GPP (SRVCC)** |  | 569d? | 2007-01-02 A | 2009-03-06 A | 100% | 2007-01-02 | 2009-03-06 | 569d? |  | S2; C1; C4 | 19856h | 19856h | SAES-SRVCC | 18 | Nokia Siemens Networks | Rel-8 | 35 | Maurice | SAES-SRVCC |  |  |  |  |
| 6623 | 2135.6.1 | Stage 2 for 2G/3G SRVCC |  | 448d? | 2007-01-02 A | 2008-09-18 A | 100% | 2007-01-02 | 2008-09-18 | 448d? | finish no earlier than 2008-09-15 | S2 | 3584h | 3584h | SAES-SRVCC | 18 | Nokia Siemens Networks | Rel-8 | 35 | Maurice |  | New 23.216 |  |  |  |
| 6624 | 2135.6.2 | Stage 3 for SRVCC in EPS |  | 201d? | 2008-05-30 A | 2009-03-06 A | 100% | 2008-05-30 | 2009-03-06 | 201d? | finish no earlier than 2009-03-06 | C1 | 1608h | 1608h | SAES-SRVCC | 21 | Nokia Siemens Networks | Rel-8 | 41 | Frederic |  | 23.009; 24.008; New 24.301 |  |  |  |
| 6625 | 2135.6.3 | MME to MSC interface for SRVCC |  | 126d? | 2008-09-12 A | 2009-03-06 A | 100% | 2008-09-12 | 2009-03-06 | 126d? | finish no earlier than 2009-03-06 | C4 | 1008h | 1008h | SAES-SRVCC | 21 | Nokia Siemens Networks | Rel-8 | 41 | Kimmo |  | 23.003; 23.008; New (29.274; 29.277; 29.280) |  |  |  |
| 6626 | 2135.7 | Voice Call Continuity for CDMA2000 1X |  | 249d? | 2007-06-25 A | 2008-06-05 A | 100% | 2007-06-25 | 2008-06-05 | 249d? | finish no earlier than 2008-06-13 | S2 | 1992h | 1992h | SAES-VCC_1X | 19 | Nokia Siemens Networks | Rel-8 | 36 | Maurice | SAES-VCC_1X |  |  |  |  |
| 6627 | 2135.8 | SAE impacts on IMS |  | 373d? | 2007-01-02 A | 2008-06-05 A | 100% | 2007-01-02 | 2008-06-05 | 373d? | finish no earlier than 2008-06-13 | S2 | 2984h | 2984h | SAES-SA_IMS | 18 | Nokia Siemens Networks | Rel-8 | 35 | Maurice | SAES-SA_IMS |  |  |  |  |
| 6628 | 2135.9 | **CS Fallback in EPS** |  | 258d? | 2008-03-12 A | 2009-03-06 A | 100% | 2008-03-12 | 2009-03-06 | 258d? |  | S2; C1; C4 | 9384h | 9384h | SAES-CSFB | 21 | T-Mobile, Vodafone | Rel-8 | 39 | Maurice | SAES-CSFB |  |  |  |  |
| 6629 | 2135.9.1 | Stage 2 for CS Fallback in EPS |  | 62d? | 2008-03-12 A | 2008-06-05 A | 100% | 2008-03-12 | 2008-06-05 | 62d? | finish no earlier than 2008-12-05 | S2 | 496h | 496h | SAES-CSFB | 21 | T-Mobile, Vodafone | Rel-8 | 40 | Maurice |  | New (23.272; 23.401) |  |  |  |
| 6630 | 2135.9.2 | CT1 part of Stage 3 for CS Fallback in EPS |  | 201d? | 2008-05-30 A | 2009-03-06 A | 100% | 2008-05-30 | 2009-03-06 | 201d? | finish no earlier than 2009-03-06 | C1 | 1608h | 1608h | SAES-CSFB | 21 | NEC | Rel-8 | 40 | Frederic |  | 24.007; 24.008; 24.011; 29.018; New (24.301; 24.801; 29.118) |  |  |  |
| 6631 | 2135.9.3 | CT4 part of Stage 3 for CS Fallback in EPS |  | 136d? | 2008-05-30 A | 2008-12-05 A | 100% | 2008-05-30 | 2008-12-05 | 136d? | finish no earlier than 2008-12-05 | C4 | 1088h | 1088h | SAES-CSFB | 21 | NEC | Rel-8 | 40 | Kimmo |  | 23.007; 23.008; 29.274; New 29.277 |  |  |  |
| 6632 | 2135.10 | System enhancements for the use of IMS services in local breakout |  | 62d? | 2008-03-12 A | 2008-06-05 A | 100% | 2008-03-12 | 2008-06-05 | 62d? | finish no earlier than 2008-06-05 | S2 | 496h | 496h | SAES-IMS_LBO | 21 | Telecom Italia | Rel-8 | 39 | Maurice | SAES-IMS_LBO | 23.228; 23.221; 23.203 |  |  |  |
| 6633 | 2135.11 | **EPC Data Definitions** |  | 309d? | 2008-01-07 A | 2009-03-12 A | 100% | 2008-01-07 | 2009-03-12 | 309d? |  | S5 | 7144h | 7144h | EPC-OAM | 21 |  | Rel-8 | 39 | Mirko | EPC-OAM |  |  |  |  |
| 6634 | 2135.11.1 | EPC Network Resource Model (NRM) Integration Reference Point (IRP) |  | 309d? | 2008-01-07 A | 2009-03-12 A | 100% | 2008-01-07 | 2009-03-12 | 309d? | finish no earlier than 2009-03-12 | S5 | 2472h | 2472h | EPC-OAM | 21 | Huawei | Rel-8 | 38 | Mirko |  | New (32.751; 32.752; 32.753; 32.755) |  |  |  |
| 6635 | 2135.11.2 | Performance measurements for EPC |  | 275d? | 2008-02-22 A | 2009-03-12 A | 100% | 2008-02-22 | 2009-03-12 | 275d? | finish no earlier than 2009-03-12 | S5 | 2200h | 2200h | EPC-OAM | 21 | China Mobile | Rel-8 | 39 | Mirko |  | New 32.426 |  |  |  |
| 6636 | 2135.12 | EPC Charging |  | 309d? | 2008-01-07 A | 2009-03-12 A | 100% | 2008-01-07 | 2009-03-12 | 309d? | finish no earlier than 2009-03-12 | S5 | 2472h | 2472h | EPC-CH | 21 | Nokia Siemens Networks | Rel-8 | 38 | Mirko | EPC-CH | 32.240; 32.296; 32.251; 32.252; 32.298; 32.299 |  |  |  |
| 6637 | 2135.13 | Domain Name System Procedures for Evolved Packet System (DEPS) |  | 179.75d? | 2008-05-30 A | 2009-03-06 A | 100% | 2008-05-30 | 2009-03-06 | 179.75d? | finish no earlier than 2009-03-06 | C4 | 1438h | 1438h | SAES-DEPS | 21 | TeliaSonera | Rel-8 | 40 | Kimmo | SAES-DEPS | 23.003; New 29.303 |  |  |  |
| 6638 | 2135.14 | InterWorking Function (IWF) between MAP based and Diameter based interfaces |  | 126d? | 2008-09-12 A | 2009-03-06 A | 100% | 2008-09-12 | 2009-03-06 | 126d? | finish no earlier than 2009-03-06 | C4 | 1008h | 1008h | SAES-MAP2Diam | 21 | Huawei | Rel-8 | 41 | Kimmo | SAES-MAP2Diam | New 29.305 |  |  |  |
| 6639 | 2135.15 | **CT6 aspects of SAE** |  | 847d? | 2008-03-07 A | 2011-06-03 A | 100% | 2008-03-07 | 2011-06-03 | 847d? |  | C6 | 13480h | 13480h | SAES | 21 | Nokia | Rel-8 | 39 | Xavier |  |  |  |  |  |
| 6640 | 2135.15.1 | Core specification for CT6 aspects of SAE |  | 321d? | 2008-03-07 A | 2009-05-29 A | 100% | 2008-03-07 | 2009-05-29 | 321d? | finish no earlier than 2009-05-29 | C6 | 2568h | 2568h | SAES | 21 | Nokia | Rel-8 | 39 | Xavier |  | 31.102; 31.111 |  |  |  |
| 6641 | 2135.15.2 | Test interworking of LTE Terminals with the USIM |  | 526d? | 2008-12-05 A | 2010-12-10 A | 100% | 2008-12-05 | 2010-12-10 | 526d? | finish no earlier than 2010-12-10 | C6 | 4208h | 4208h | SAES-USIM_LTE-Test | 22 | Comprion | Rel-8 | 42 | Xavier | SAES-USIM_LTE-Test | 31.121; 31.124 |  |  |  |
| 6642 | 2135.15.3 | Test interworking of IP Multimedia Services Identity Module (ISIM) terminals with IP Multimedia Subsystem (IMS) |  | 186d? | 2010-09-17 A | 2011-06-03 A | 100% | 2010-09-17 | 2011-06-03 | 186d? | finish no earlier than 2011-06-03 | C6 | 1488h | 1488h | SAES-ISIM_IMS_Test | 25 | Comprion | Rel-8 | 49 | Xavier | SAES-ISIM_IMS_Test | 31.121; 31.124; New 31.134 |  |  |  |
| 6643 | 2135.16 | Issues for CT1 TR 24.801 |  | 420d? | 2007-01-04 A | 2008-12-05 A | 100% | 2007-01-04 | 2008-12-05 | 420d? | finish no earlier than 2008-12-05 | C1 | 3360h | 3360h | SAES | 21 | Nokia Siemens Networks | Rel-8 | 39 | Frederic |  | 24.801 |  |  |  |
| 6644 | 2135.17 | Issues for CT3 TR 29.804 |  | 420d? | 2007-02-05 A | 2008-09-12 A | 100% | 2007-02-05 | 2008-09-12 | 420d? | finish no earlier than 2008-12-12 | C3 | 3360h | 3360h | SAES | 21 | Ericsson | Rel-8 | 39 | Adrian |  | 29.804 |  |  |  |
| 6645 | 2135.18 | Deleted - Issues for CT4 TR 29.803 |  | 420d? | 2007-01-04 A | 2008-09-12 A | 100% | 2007-01-04 | 2008-09-12 | 420d? | finish no earlier than 2008-12-11 | C4 | 3360h | 3360h | SAES | 21 | Huawei | Rel-8 | 39 | Kimmo |  | 29.803 | PCG-21 | CP-41 |  |
| 6646 | 2135.19 | Deleted (covered by 380068): Functions and procedures for SAE to support LCS | milestone | 0d? | 2008-03-03 A | 2008-03-03 A | 100% | 2008-03-03 | 2008-03-03 | 0d? | finish no earlier than 2008-03-03 | S2 |  |  | SAES-SA-FP_LCS | 18 | Nokia Siemens Networks | Rel-8 | 35 | Maurice | SAES-SA-FP_LCS |  |  | SP-37 |  |
| 6647 | 2135.20 | Deleted (covered by 380064): SAE aspects of Emergency Calls | milestone | 0d? | 2008-03-03 A | 2008-03-03 A | 100% | 2008-03-03 | 2008-03-03 | 0d? | start no earlier than 2008-03-03 | S2 |  |  | SAES-SA-EmCall | 18 | Nokia Siemens Networks | Rel-8 | 35 | Maurice | SAES-SA-EmCall |  |  | SP-37 | Public Safety (I-A) |

Notes:
- 6622: CP#43 completed. SP#38 WID approved (extract from SAE WID SP-070817). / WI rapporteur e-mail: curt.c.wong@nokia.com
- 6623: SP#41 completed. SP#38 WID approved / WI rapporteur e-mail: curt.c.wong@nokia.com
- 6624: CP#43 completed / WI rapporteur e-mail: robert.zaus@nsn.com
- 6625: CP#43 completed / WI rapporteur e-mail: Giorgi Gulbani
- 6626: SP#40 completed / WI rapporteur e-mail: balazs.bertenyi@nsn.com
- 6627: SP#40 completed / WI rapporteur e-mail: balazs.bertenyi@nsn.com
- 6628: CP#43 completed / WI rapporteur e-mail: sabine.demel@t-mobile.at, chris.pudney@vodafone.com
- 6629: SP#40 completed / WI rapporteur e-mail: sabine.demel@t-mobile.at, chris.pudney@vodafone.com
- 6630: CP#43 completed / WI rapporteur e-mail: yannick.lair@nectech.fr
- 6631: CP#42 completed / WI rapporteur e-mail: yannick.lair@nectech.fr
- 6632: SP#40 completed / WI rapporteur e-mail: mario.madella@telecomitalia.it
- 6633: SP#43 completed
- 6634: SP#43 completed / WI rapporteur e-mail: WANG, Xuelong
- 6635: SP#43 completed / WI rapporteur e-mail: Li Jian (lijian@chinamobile.com), Liang Shuangchun (liangshuangchun@cmdi.chinamobile.com)
- 6636: SP#43 completed / WI rapporteur e-mail: Gerald.Goermer@nsn.com
- 6637: CP#43 completed / WI rapporteur e-mail: jouni.korhonen@teliasonera.com
- 6638: CP#43 completed. Triggered by UID_380023 (FS_MAP2Diam) / WI rapporteur e-mail: liming49985@huawei.com
- 6639: CP#44 completed core specification / WI rapporteur e-mail: Rune Lindholm
- 6640: CP#44 completed (specified Network Measurement Results collection via USAT) / WI rapporteur e-mail: Rune Lindholm
- 6641: CP#50 completed. Steering of Roaming test cases have been introduced. Remaining issues CSG display testing (Provide Local Information, Call Control for EPS/PDN, Event Download (Access Technology Change - Multiple Access Technologies) / WI rapporteur e-mail: Udo Willenbrink (uwillenbrink@comprion.com )
- 6642: CP#52 completed. Linked to R5 UID_1273 Provisioning of IP-based multimedia services (24.229, 31.103), R8 UID_390021 CT6 aspects of SAE, UID_420018 Test interworking of LTE Terminals with the USIM, R UID_450018 Testing SMS over IMS in E-UTRAN (34.229). / WI rapporteur e-mail: Udo Willenbrink (uwillenbrink@comprion.com )
- 6643: CP#43 completed / WI rapporteur e-mail: robert.zaus@nsn.com
- 6644: CP#41 completed / WI rapporteur e-mail: j.javier.pastor@ericsson.com
- 6645: CP#41 Work stopped and continued in Normative specifications
- 6646: SP#37 stopped
- 6647: SP#37 stopped

| ID | WBS | Task | Type | Duration | Start | Finish | Complete | Baseline start | Baseline finish | Baseline duration | Constraint | Resources | Work | Actual work | Acronym | PCG approved | Release | TSG approved | MCC resp | TSG stopped | Acronym_3GU_Export | WI rapporteur name | WI rapporteur e-mail | Status Report | PCG stopped |
| --- | --- | --- | --- | --- | --- | --- | --- | --- | --- | --- | --- | --- | --- | --- | --- | --- | --- | --- | --- | --- | --- | --- | --- | --- | --- |
| 6648 | 2135.21 | **Deleted - CT aspects of SAES** |  | 138d? | 2007-09-04 A | 2008-03-14 A | 100% | 2007-09-04 | 2008-03-14 | 138d? |  | C3; C1; C4 | 1104h | 1104h | SAES-St3 | 18 | Rel-8 | 34 | Frederic | SP-37 | SAES-St3 |  |  |  |  |
| 6649 | 2135.21.1 | Deleted - CT1 aspects of SAES | milestone | 0d? | 2007-09-04 A | 2007-09-04 A | 100% | 2007-09-04 | 2007-09-04 | 0d? | start no earlier than 2007-09-04 | C1 |  |  | SAES-St3 | 18 | Rel-8 | 35 | Frederic | SP-37 |  |  |  |  |  |
| 6650 | 2135.21.2 | Deleted - Interoperability | milestone | 0d? | 2008-03-14 A | 2008-03-14 A | 100% | 2008-03-14 | 2008-03-14 | 0d? | start no earlier than 2008-03-14 | C1 |  |  | SAES-St3-interop | 18 | Rel-8 | 34 | Frederic | SP-37 | SAES-St3-interop |  |  |  |  |
| 6651 | 2135.21.3 | Deleted - CT3 aspects of SAES | milestone | 0d? | 2007-09-04 A | 2007-09-04 A | 100% | 2007-09-04 | 2007-09-04 | 0d? | start no earlier than 2007-09-04 | C3 |  |  | SAES | 18 | Rel-8 | 35 | Adrian | SP-37 |  |  |  |  |  |
| 6652 | 2135.21.4 | Deleted - CT4 aspects of SAES | milestone | 0d? | 2007-09-04 A | 2007-09-04 A | 100% | 2007-09-04 | 2007-09-04 | 0d? | start no earlier than 2007-09-04 | C4 |  |  | SAES | 18 | Rel-8 | 35 | Kimmo | SP-37 |  |  |  |  |  |
| 6653 | 2135.21.5 | Deleted - UE to EPC NAS signalling (incl. MBMS and QoS aspects) | milestone | 0d? | 2008-03-14 A | 2008-03-14 A | 100% | 2008-03-14 | 2008-03-14 | 0d? | start no earlier than 2008-03-14 | C1 |  |  | SAES-St3-sig | 18 | Rel-8 | 34 | Frederic | SP-37 | SAES-St3-sig |  |  |  |  |
| 6654 | 2135.21.6 | Deleted - User and Control plane protocols | milestone | 0d? | 2007-09-21 A | 2007-09-21 A | 100% | 2007-09-21 | 2007-09-21 | 0d? | start no earlier than 2007-09-21 | C4 |  |  | SAES-St3-prot | 18 | Rel-8 | 34 | Kimmo | SP-37 | SAES-St3-prot |  |  |  |  |
| 6655 | 2135.22 | Deleted - Architecture enhancements for non-3GPP accesses | milestone | 0d? | 2007-09-04 A | 2007-09-04 A | 100% | 2007-09-04 | 2007-09-04 | 0d? | start no earlier than 2007-09-04 | S2 |  |  | SAES-non_3GPP | 18 | Rel-8 | 34 | Maurice | SP-34 | SAES-non_3GPP | Motorola | Irfan.Ali@motorola.com |  |  |
| 6656 | 2135.23 | Deleted - Stage 2 of architecture for the 3GPP System Architecture Evolution | milestone | 0d? | 2007-10-02 A | 2007-10-02 A | 100% | 2007-10-02 | 2007-10-02 | 0d? | start no earlier than 2007-10-02 | S2 |  |  | SAES-St2 | 17 | Rel-8 | 32 | Maurice | SP-34 | SAES-St2 | Vodafone | chris.pudney@vodafone.com |  |  |
| 6657 | 2135.24 | Deleted - SA aspects of System Architecture Evolution |  | 384d? | 2006-04-12 A | 2007-10-01 A | 100% | 2006-04-12 | 2007-10-01 | 384d? | finish no earlier than 2007-10-02 | S2 | 3072h | 3072h | SAES-SA | 18 | Rel-8 | 35 | Maurice | SP-34 | SAES-SA |  |  |  |  |
| 6658 | 2136 | Conformance Test Aspects – Mobility management based on DSMIPv6 (Dual-Stack Mobile IPv6) |  | 261d? | 2009-09-18 A | 2010-09-17 A | 100% | 2009-09-18 | 2010-09-17 | 261d? | finish no earlier than 2010-09-17 | R5 | 2088h | 2088h | DSMIPv6_UEConTest | 23 | Rel-8 | 45 | Ingbert |  | DSMIPv6_UEConTest | Qualcomm | Lena Chaponniere (lchaponn@qualcomm.com) | RP-100738 |  |
| 6659 | 2137 | **IMS Centralized Service control** |  | 2392.1d? | 2005-11-01 A | 2014-12-09 A | 100% | 2005-11-01 | 2014-12-05 | 2387.1d? |  | S1; S2; C1; C3; C4; IETF | 239598h | 239598h | ICSRA | 19 | Rel-8 | 37 | Alain |  | ICSRA | AT&T | Randolph Wohlert (rwohlert@tri.sbc.com) |  |  |
| 6660 | 2137.1 | Stage 1 for ICS Requirement and Architecture |  | 138d? | 2007-09-03 A | 2008-03-12 A | 100% | 2007-09-03 | 2008-03-12 | 138d? | finish no earlier than 2007-12-14 | S1 | 1104h | 1104h | ICSRA | 21 | Rel-8 | 38 | Alain |  |  | AT&T | Randolph Wohlert (rwohlert@tri.sbc.com) |  |  |
| 6661 | 2137.2 | Stage 2 for ICS Requirement and Architecture |  | 125d? | 2007-12-14 A | 2008-06-05 A | 100% | 2007-12-14 | 2008-06-05 | 125d? | start no earlier than 2007-12-14 | S2 | 1000h | 1000h | ICSRA-St2 | 21 | Rel-8 | 38 | Maurice |  | ICSRA-St2 | Alcatel-Lucent |  |  |  |
| 6662 | 2137.3 | **Stage 3 for ICSRA – Protocol, Addressing, Subscriber Data** |  | 2392.1d? | 2005-11-01 A | 2014-12-09 A | 100% | 2005-11-01 | 2014-12-05 | 2387.1d? |  | C1; C3; C4; IETF | 122674h | 122674h | ICSRA |  | Rel-8 |  | Frederic |  |  | Ericsson | sean.schneyer@ericsson.com |  |  |
| 6663 | 2137.3.1 | CT1 aspects - Stage 3 for ICSRA |  | 201d? | 2008-05-30 A | 2009-03-06 A | 100% | 2008-05-30 | 2009-03-06 | 201d? | finish no earlier than 2009-03-06 | C1 | 1608h | 1608h | ICSRA | 21 | Rel-8 | 40 | Frederic |  |  | Ericsson | Sean Schneyer |  |  |
| 6664 | 2137.3.2 | (IETF) CT1 aspects - Stage 3 for ICSRA (draft-ietf-salud-alert-info-urns) |  | 1244d? | 2008-05-30 A | 2014-12-09 A | 100% | 2008-05-30 | 2014-12-05 | 1242d? | finish no earlier than 2014-12-09 | C1-IETF | 9952h | 9952h | ICSRA | 27 | Rel-8 | 52 | Frederic |  |  | Roland Jesske | Roland Jesske |  |  |
| 6665 | 2137.3.3 | (IETF) CT1 aspects - Stage 3 for ICSRA (RFC 6871) |  | 779d? | 2008-05-30 A | 2013-03-01 A | 100% | 2008-05-30 | 2013-03-01 | 779d? | finish no earlier than 2013-02-28 | C1-IETF | 6232h | 6232h | ICSRA | 27 | Rel-8 | 52 | Frederic |  |  | Andrew Allen |  |  |  |
| 6666 | 2137.3.4 | (IETF) CT1 aspects - Stage 3 for ICSRA (RFC 7195) |  | 1117d? | 2008-05-30 A | 2014-06-13 A | 100% | 2008-05-30 | 2014-06-13 | 1117d? | finish no earlier than 2014-06-13 | C1-IETF | 8936h | 8936h | ICSRA | 27 | Rel-8 | 52 | Frederic |  |  | Andrew Allen |  |  |  |
| 6667 | 2137.3.5 | (IETF) CT1 aspects - Stage 3 for ICSRA (RFC 7006) |  | 977d? | 2008-06-03 A | 2013-12-06 A | 100% | 2008-06-03 | 2013-12-06 | 977d? | finish no earlier than 2013-12-06 | C1-IETF | 7816h | 7816h | ICSRA | 27 | Rel-8 | 52 | Frederic |  |  | Andrew Allen |  |  |  |
| 6668 | 2137.3.6 | CT3 aspects - Stage 3 for ICSRA |  | 201d? | 2008-05-30 A | 2009-03-06 A | 100% | 2008-05-30 | 2009-03-06 | 201d? | finish no earlier than 2009-03-06 | C3 | 1608h | 1608h | ICSRA | 21 | Rel-8 | 40 | Adrian |  |  | Mavenir | Brett Wallis ( brett@mavenir.com) |  |  |
| 6669 | 2137.3.7 | CT4 aspects - Stage 3 for ICSRA |  | 136d? | 2008-05-30 A | 2008-12-05 A | 100% | 2008-05-30 | 2008-12-05 | 136d? | start no earlier than 2008-05-30 | C4 | 1088h | 1088h | ICSRA | 21 | Rel-8 | 40 | Kimmo |  |  | Ericsson | Sean Schneyer |  |  |
| 6670 | 2137.3.8 | (IETF) CT4 aspects - Stage 3 for ICSRA (RFC 7254) |  | 1034.8d? | 2005-11-01 A | 2014-06-13 A | 100% | 2005-11-01 | 2014-06-13 | 1034.8d? | finish no earlier than 2014-06-13 | C4-IETF | 8278.4h | 8278.4h | ICSRA | 27 | Rel-8 | 52 | Kimmo |  |  | Andrew Allen |  |  |  |
| 6671 | 2137.3.9 | Deleted - Stage 3 for ICSRA – I1 interface |  | 76d? | 2008-05-30 A | 2008-09-12 A | 100% | 2008-05-30 | 2008-09-12 | 76d? | finish no earlier than 2008-09-12 | C1 | 608h | 608h | ICSRA | 21 | Rel-8 | 40 | Frederic | CP-41 |  | Huawei | xupeili@huawei.com |  | PCG-21 |

Notes:
- 6648: SP#37 stopped
- 6649: SP#37 stopped
- 6650: SP#37 stopped
- 6651: SP#37 stopped
- 6652: SP#37 stopped / Impacted TSs and TRs: 29.803
- 6653: SP#37 stopped
- 6654: SP#37 stopped
- 6655: SP#34 stopped. Replaced by UID_350027 and its children / Impacted TSs and TRs: 23.402
- 6656: SP#34 stopped. Replaced by UIDs 340018 and 340037. (SP#34 report discussion of SP-060917.) / Impacted TSs and TRs: 23.002; 23.060; 23.107; 23.203; 23.228; 23.234; 23.246; 23.271; 23.279
- 6657: SP#34 stopped
- 6658: RP#49 completed. Testing for CT1's UID_360022 (24.303) under Rel-8 Feature SAES / Impacted TSs and TRs: 36.508; 36.523-1; 36.523-2; 36.523-3
- 6659: CP#46 completed
- 6660: SP#39 completed / Impacted TSs and TRs: 22.101
- 6661: SP#40 completed / Impacted TSs and TRs: 23.292; 23.206
- 6662: CP#46 completed
- 6663: CP#46 completed / Impacted TSs and TRs: 24.229; new (24.292; 24.286)
- 6664: In RFC Editors Queue. Dec.14: 75->90¦7/3/16: 90%->100; 9/4/21: RFC 7462 added; / Impacted TSs and TRs: draft-ietf-salud-alert-info-urns; RFC 7462
- 6665: CP#59 completed / Impacted TSs and TRs: RFC 6871 (was draft-ietf-mmusic-sdp-media-capabilities)
- 6666: CP#64 complete / Impacted TSs and TRs: RFC 7195 (was draft-ietf-mmusic-sdp-cs)
- 6667: CP#62 completed / Impacted TSs and TRs: RFC7006 (was draft-ietf-mmusic-sdp-miscellaneous-caps)
- 6668: CP#43 completed / Impacted TSs and TRs: new 29.292
- 6669: CP#42 completed / Impacted TSs and TRs: 23.003; 29.232; 23.018; 29.002
- 6670: CP#64 complete / Impacted TSs and TRs: RFC 7254 (was draft-montemurro-gsma-imei-urn)
- 6671: CP#41 work stopped / Impacted TSs and TRs: 24.293

| ID | WBS | Task | Duration | Start | Finish | Complete | Baseline start | Baseline finish | Baseline duration | Constraint | Resources | Work | Actual work | Acronym | PCG approved | Release | TSG approved | MCC resp | Acronym_3GU_Export | WI rapporteur name | WI rapporteur e-mail |
| --- | --- | --- | --- | --- | --- | --- | --- | --- | --- | --- | --- | --- | --- | --- | --- | --- | --- | --- | --- | --- | --- |
| 6672 | 2138 | **IMS Multimedia Telephony and Supplementary Services** | 2002d? | 2007-05-02 A | 2014-12-09 A | 100% | 2007-05-02 | 2014-12-05 | 1997d? |  | S1; S5; C1; C3; C4; IETF | 272222h | 272222h | IMSTSS | 19 | Rel-8 | 37 | Alain | IMSTSS |  |  |
| 6673 | 2138.1 | **General aspects of IMS Sup Services** | 395d? | 2007-09-03 A | 2009-03-06 A | 100% | 2007-09-03 | 2009-03-06 | 395d? |  | S1; C1; C3; C4 | 19232h | 19232h | IMSSS-Gal | 19 | Rel-8 | 37 | Alain | IMSSS-Gal | Ericsson | Susana Sabater |
| 6674 | 2138.1.1 | Service and Capability for Core IMS - inclusion of TISPAN requirements | 75d? | 2007-09-03 A | 2007-12-14 A | 100% | 2007-09-03 | 2007-12-14 | 75d? | finish no earlier than 2007-12-14 | S1 | 600h | 600h | TISCAPR8 | 19 | Rel-8 | 37 | Alain | TISCAPR8 | Ericsson | Susana Sabater |
| 6675 | 2138.1.2 | Documentation of TISPAN R1 and R2 in CT1 | 208d? | 2007-11-28 A | 2008-09-12 A | 100% | 2007-11-28 | 2008-09-12 | 208d? | finish no earlier than 2008-09-12 | C1 | 1664h | 1664h | REDOC_TIS-C1 | 21 | Rel-8 | 38 | Frederic | REDOC_TIS-C1 | Nokia Siemens Networks | peter.leis@nsn.com |
| 6676 | 2138.1.3 | Documentation of TISPAN R1 and R2 in CT3 | 333d? | 2007-11-28 A | 2009-03-06 A | 100% | 2007-11-28 | 2009-03-06 | 333d? | finish no earlier than 2009-03-06 | C3 | 2664h | 2664h | REDOC_TIS-C3 | 21 | Rel-8 | 38 | Adrian | REDOC_TIS-C3 | Nokia Siemens Networks | peter.leis@nsn.com |
| 6677 | 2138.1.4 | Documentation of TISPAN R1 and R2 in CT4 | 208d? | 2007-11-28 A | 2008-09-12 A | 100% | 2007-11-28 | 2008-09-12 | 208d? | finish no earlier than 2008-09-12 | C4 | 1664h | 1664h | REDOC_TIS-C4 | 21 | Rel-8 | 38 | Kimmo | REDOC_TIS-C4 | Nokia Siemens Networks | peter.leis@nsn.com |
| 6678 | 2138.2 | **IMS Multimedia Telephony Service** | 394d? | 2007-09-10 A | 2009-03-12 A | 100% | 2007-09-10 | 2009-03-12 | 394d? |  | S1; S5 | 9296h | 9296h | IMS-MMTel | 19 | Rel-8 | 37 | Alain | IMS-MMTel |  |  |
| 6679 | 2138.2.1 | Merging TISPAN MMTel [requirements] for Common IMS | 65d? | 2007-09-10 A | 2007-12-07 A | 100% | 2007-09-10 | 2007-12-07 | 65d? | finish no earlier than 2007-12-07 | S1 | 520h | 520h | TMMTEL | 19 | Rel-8 | 37 | Alain | TMMTEL | Nokia Siemens Networks |  |
| 6680 | 2138.2.2 | Multimedia Telephony Service and Supplementary Services (MMTel) offline Charging | 309d? | 2008-01-07 A | 2009-03-12 A | 100% | 2008-01-07 | 2009-03-12 | 309d? | finish no earlier than 2009-03-12 | S5 | 2472h | 2472h | MMTel-CH | 21 | Rel-8 | 38 | Mirko | MMTel-CH | Alcatel-Lucent | maryse.gardella@alcatel-lucent.com |
| 6681 | 2138.3 | **Call Completion on Busy Subscriber (CCBS)/Call Completion on Non-Reachable (CCNR) on IMS** | 1608d? | 2007-05-02 A | 2013-06-14 A | 100% | 2007-05-02 | 2013-06-14 | 1608d? |  | C1; C3; IETF | 71528h | 71528h | CCBS_CCNR | 21 | Rel-8 | 38 | Frederic | CCBS_CCNR | Deutsche Telekom | martin.huelsemann@telekom.de |
| 6682 | 2138.3.1 | CT1 part of Stage 3 CCBS_CCNR | 483d? | 2007-05-02 A | 2009-03-06 A | 100% | 2007-05-02 | 2009-03-06 | 483d? | finish no earlier than 2009-03-06 | C1 | 3864h | 3864h | CCBS_CCNR | 21 | Rel-8 | 38 | Frederic |  | Deutsche Telekom | martin.huelsemann@telekom.de |
| 6683 | 2138.3.2 | CT3 part of Stage 3 CCBS_CCNR | 418d? | 2007-05-02 A | 2008-12-05 A | 100% | 2007-05-02 | 2008-12-05 | 418d? | finish no earlier than 2008-12-05 | C3 | 3344h | 3344h | CCBS_CCNR | 21 | Rel-8 | 38 | Adrian |  | Deutsche Telekom | martin.huelsemann@telekom.de |
| 6684 | 2138.3.3 | (IETF) Stage 3 CCBS_CCNR [RFC 6910 (was draft-ietf-bliss-call-completion)] | 1608d? | 2007-05-02 A | 2013-06-14 A | 100% | 2007-05-02 | 2013-06-14 | 1608d? | finish no earlier than 2013-06-10 | C1-IETF; C3-IETF | 25728h | 25728h | CCBS_CCNR | 27 | Rel-8 | 52 | Frederic |  | Roland Jesske |  |
| 6685 | 2138.4 | **Flexible Alerting** | 288d? | 2008-01-30 A | 2009-03-06 A | 100% | 2008-01-30 | 2009-03-06 | 288d? |  | S1; C1 | 7582.4h | 7582.4h | FA | 21 | Rel-8 | 39 | Alain | FA | Nortel | milanpa@nortel.com |
| 6686 | 2138.4.1 | Stage 1 FA | 92d? | 2008-01-30 A | 2008-06-05 A | 100% | 2008-01-30 | 2008-06-05 | 92d? |  | S1 | 670.4h | 670.4h | FA | 21 | Rel-8 | 39 | Alain |  | Telecom Italia |  |
| 6687 | 2138.4.2 | Stage 3 FA | 288d? | 2008-01-30 A | 2009-03-06 A | 100% | 2008-01-30 | 2009-03-06 | 288d? | finish no earlier than 2009-03-06 | C1 | 2304h | 2304h | FA | 21 | Rel-8 | 39 | Frederic |  | Nortel | milanpa@nortel.com |
| 6688 | 2138.5 | **Communication Wait on IMS** | 1965d? | 2007-06-22 A | 2014-12-09 A | 100% | 2007-06-22 | 2014-12-05 | 1960d? |  | C1; C3; IETF | 61880h | 61880h | CW_IMS | 21 | Rel-8 | 38 | Frederic | CW_IMS | Deutsche Telekom | martin.huelsemann@telekom.de |
| 6689 | 2138.5.1 | CT1 part of Stage 3 CW-IMS | 331d? | 2007-11-30 A | 2009-03-06 A | 100% | 2007-11-30 | 2009-03-06 | 331d? | finish no earlier than 2009-03-06 | C1 | 2648h | 2648h | CW_IMS | 21 | Rel-8 | 38 | Frederic |  | Deutsche Telekom | martin.huelsemann@telekom.de |
| 6690 | 2138.5.2 | (IETF) Stage 3 CW-IMS (salud-alert-info-urns) | 1244d? | 2007-06-22 A | 2014-12-09 A | 100% | 2007-06-22 | 2014-12-05 | 1242d? | finish no earlier than 2014-12-09 | C1-IETF | 9952h | 9952h | CW_IMS | 27 | Rel-8 | 52 | Frederic |  | Roland Jesske | Roland Jesske |
| 6691 | 2138.5.3 | CT3 part of Stage 3 CW-IMS | 265d? | 2007-11-30 A | 2008-12-04 A | 100% | 2007-11-30 | 2008-12-04 | 265d? | finish no earlier than 2008-12-05 | C3 | 2120h | 2120h | CW_IMS | 21 | Rel-8 | 38 | Adrian |  | Deutsche Telekom | martin.huelsemann@telekom.de |
| 6692 | 2138.6 | **IMS Charging** | 389d? | 2007-09-17 A | 2009-03-12 A | 100% | 2007-09-17 | 2009-03-12 | 389d? |  | S5 | 6608h | 6608h | CH8_IMS | 19 | Rel-8 | 37 | Mirko | CH8 | Alcatel-Lucent | maryse.gardella@alcatel-lucent.com |
| 6693 | 2138.6.1 | Add Interconnection Border Control Function (IBCF) to IMS Charging | 128d? | 2007-09-17 A | 2008-03-12 A | 100% | 2007-09-17 | 2008-03-12 | 128d? | finish no earlier than 2008-03-12 | S5 | 1024h | 1024h | CH8_IMS | 19 | Rel-8 | 37 | Mirko |  | Alcatel-Lucent | maryse.gardella@alcatel-lucent.com |
| 6694 | 2138.6.2 | Advice of Charge (AoC) support in IMS Charging | 309d? | 2008-01-07 A | 2009-03-12 A | 100% | 2008-01-07 | 2009-03-12 | 309d? | finish no earlier than 2009-03-12 | S5 | 2472h | 2472h | CH8_IMS | 21 | Rel-8 | 38 | Mirko |  | Nokia Siemens Networks | Gerald.Goermer@nsn.com |
| 6695 | 2139 | **3GPP2 Input to Common IMS** | 200d? | 2008-03-07 A | 2008-12-11 A | 100% | 2008-03-07 | 2008-12-11 | 200d? |  | S1; S2; S3; C1; C3; C4 | 21453.2h | 21453.2h | CIMS_3GPP2 | 21 | Rel-8 | 39 | Alain | CIMS_3GPP2, IMS_Common | Nortel | Amar Deol (deola@nortelnetworks.com) |
| 6696 | 2139.1 | Stage 1 CIMS_3GPP2 | 30.65d? | 2008-03-12 A | 2008-06-05 A | 100% | 2008-03-12 | 2008-06-05 | 30.65d? | finish no earlier than 2008-06-12 | S1 | 245.2h | 245.2h | CIMS_3GPP2 | 21 | Rel-8 | 39 | Alain |  | Nortel | Amar Deol (deola@nortelnetworks.com) |
| 6697 | 2139.2 | Stage 2 CIMS_3GPP2 | 62d? | 2008-03-12 A | 2008-06-05 A | 100% | 2008-03-12 | 2008-06-05 | 62d? | finish no earlier than 2008-09-11 | S2 | 496h | 496h | CIMS_3GPP2 | 21 | Rel-8 | 39 | Maurice |  | Nortel | Amar Deol (deola@nortelnetworks.com) |
| 6698 | 2139.3 | Security CIMS_3GPP2 | 197d? | 2008-03-12 A | 2008-12-11 A | 100% | 2008-03-12 | 2008-12-11 | 197d? | finish no earlier than 2008-12-11 | S3 | 1576h | 1576h | CIMS_3GPP2 | 21 | Rel-8 | 39 | Mirko |  | Nortel | Amar Deol (deola@nortelnetworks.com) |

Notes:
- 6672: SP#43 completed
- 6673: CP#43 completed
- 6674: SP#39 completed / Impacted TSs and TRs: 22.228; 22.115; 22.101
- 6675: CP#41 completed / Impacted TSs and TRs: 24.141; 24.147; 24.173; 24.229; 24.247; 24.341; 24.604; 24.605; 24.606; 24.607; 24.608; 24.610; 24.611; 24.616; 24.623; 24.628; 24.629; 24.647; 24.654
- 6676: CP#43 completed / Impacted TSs and TRs: 29.162; 29.163; 29.658
- 6677: CP#41 completed / Impacted TSs and TRs: 29.228; 29.229
- 6678: SP#43 completed
- 6679: SP#38 completed / Impacted TSs and TRs: 22.173
- 6680: CP#43 completed / Impacted TSs and TRs: 32.275; 32.298/299
- 6681: CP#43 completed
- 6682: CP#43 completed / Impacted TSs and TRs: 24.642; 24.229; 24.173
- 6683: CP#42 completed / Impacted TSs and TRs: 29.163
- 6684: CP#60 completed / Impacted TSs and TRs: RFC 6910 (was draft-ietf-bliss-call-completion)
- 6685: CP#43 completed
- 6686: SP#40 completed / Impacted TSs and TRs: 22.173
- 6687: CP#43 completed / Impacted TSs and TRs: 24.239; 24.173
- 6688: CP#43 completed
- 6689: CP#43 completed / Impacted TSs and TRs: 24.615; 24.229; 24.173
- 6690: In RFC Editors Queue. Dec.14: 75->90¦7/3/16: 90%->100; 9/4/21: RFC 7462 added; / Impacted TSs and TRs: draft-ietf-salud-alert-info-urns; RFC 7462
- 6691: CP#42 completed / Impacted TSs and TRs: 29.163
- 6692: SP#39 completed / Impacted TSs and TRs: 32.260; 32.298
- 6693: SP#39 completed / Impacted TSs and TRs: 32.260; 32.298
- 6694: SP#43 completed / Impacted TSs and TRs: 32.240; 32.260; 32.296; 32.298; 32.299; new 32.280
- 6695: TSG#42 completed. Acronym changed from "CIMS_3GPP2, IMS_Common"
- 6696: SP#40 completed. Acronym changed from "CIMS_3GPP2, IMS_Common" / Impacted TSs and TRs: 22.228; 22.173; 22.101; 22.153
- 6697: SP#40 completed. Acronym changed from "CIMS_3GPP2, IMS_Common" / Impacted TSs and TRs: 23.002; 23.141; 23.203; 23.167; 23.228
- 6698: SP#42 completed [issues addressed under UID_370078 (IMS-Sec)]. Acronym changed from "CIMS_3GPP2, IMS_Common" / Impacted TSs and TRs: 33.141; 33.203; 33.210

| ID | WBS | Task | Duration | Start | Finish | Complete | Baseline start | Baseline finish | Baseline duration | Constraint | Resources | Work | Actual work | Acronym | PCG approved | WI rapporteur name | WI rapporteur e-mail | Release | TSG approved | MCC resp | Acronym_3GU_Export | TSG stopped |
| --- | --- | --- | --- | --- | --- | --- | --- | --- | --- | --- | --- | --- | --- | --- | --- | --- | --- | --- | --- | --- | --- | --- |
| 6699 | 2139.4 | **Stage 3 CIMS_3GPP2** | 200d? | 2008-03-07 A | 2008-12-11 A | 100% | 2008-03-07 | 2008-12-11 | 200d? |  | C1; C3; C4 | 9536h | 9536h | REDOC_3GPP2 | 21 | Alcatel-Lucent | orsic@alcatel-lucent.com | Rel-8 | 39 | Frederic | REDOC_3GPP2 |  |
| 6700 | 2139.4.1 | Stage 3 CIMS_3GPP2 (CT1) | 196d? | 2008-03-07 A | 2008-12-05 A | 100% | 2008-03-07 | 2008-12-05 | 196d? | finish no earlier than 2008-12-11 | C1 | 1568h | 1568h | REDOC_3GPP2 | 21 | Alcatel-Lucent | orsic@alcatel-lucent.com | Rel-8 | 39 | Frederic |  |  |
| 6701 | 2139.4.2 | Stage 3 CIMS_3GPP2 (CT3) | 196d? | 2008-03-07 A | 2008-12-05 A | 100% | 2008-03-07 | 2008-12-05 | 196d? | finish no earlier than 2008-12-05 | C3 | 1568h | 1568h | REDOC_3GPP2 | 21 | Alcatel-Lucent | orsic@alcatel-lucent.com | Rel-8 | 39 | Adrian |  |  |
| 6702 | 2139.4.3 | Stage 3 CIMS_3GPP2 (CT4) | 200d? | 2008-03-07 A | 2008-12-11 A | 100% | 2008-03-07 | 2008-12-11 | 200d? | finish no earlier than 2008-12-11 | C4 | 1600h | 1600h | REDOC_3GPP2 | 21 | Alcatel-Lucent | orsic@alcatel-lucent.com | Rel-8 | 39 | Kimmo |  |  |
| 6703 | 2140 | **IMS Enhancements for support of Packet Cable access** | 388d? | 2006-12-06 A | 2008-05-30 A | 100% | 2006-12-06 | 2008-05-30 | 388d? |  | S2; S3; C1; C3; C4 | 58616h | 58616h | PktCbl | 18 | Cablelabs | Bernie McKibben (b.mckibben@cablelabs.com) | Rel-8 | 35 | Maurice | PktCbl |  |
| 6704 | 2140.1 | **IMS Enhancements for Cable Client Types and Deployment Models** | 345d? | 2007-02-05 A | 2008-05-30 A | 100% | 2007-02-05 | 2008-05-30 | 345d? |  | S2; C1 | 9752h | 9752h | PktCbl-Deploy | 18 | Cablelabs | Bernie McKibben (b.mckibben@cablelabs.com) | Rel-8 | 35 | Maurice | PktCbl-Deploy |  |
| 6705 | 2140.1.1 | Architecture aspects of PktCbl-Deploy | 219d? | 2007-02-05 A | 2007-12-06 A | 100% | 2007-02-05 | 2007-12-06 | 219d? | finish no earlier than 2007-12-03 | S2 | 1752h | 1752h | PktCbl-Deploy | 18 | Cablelabs | Bernie McKibben (b.mckibben@cablelabs.com) | Rel-8 | 35 | Maurice |  |  |
| 6706 | 2140.1.2 | CT1 aspects of PktCbl-Deploy | 310d? | 2007-03-26 A | 2008-05-30 A | 100% | 2007-03-26 | 2008-05-30 | 310d? | finish no earlier than 2008-06-15 | C1 | 2480h | 2480h | PktCbl-Deploy | 18 | Cablelabs | D.Hancock@CableLabs.com | Rel-8 | 35 | Frederic |  |  |
| 6707 | 2140.2 | **IMS Inter-working aspects in Support of Cable Regulatory requirements** | 290d? | 2007-02-05 A | 2008-03-14 A | 100% | 2007-02-05 | 2008-03-14 | 290d? |  | S2; C1; C3 | 12320h | 12320h | PktCbl-Intw | 18 | Cablelabs | B.McKibben@CableLabs.com | Rel-8 | 35 | Maurice | PktCbl-Intw |  |
| 6708 | 2140.2.1 | Architecture aspects of PktCbl-Interwork | 160d? | 2007-02-05 A | 2007-09-14 A | 100% | 2007-02-05 | 2007-09-14 | 160d? | start no earlier than 2007-02-05 | S2 | 1280h | 1280h | PktCbl-Intw | 18 | Cablelabs | B.McKibben@CableLabs.com | Rel-8 | 35 | Maurice |  |  |
| 6709 | 2140.2.2 | CT1,CT3 aspects of PktCbl-Interwork | 255d? | 2007-03-26 A | 2008-03-14 A | 100% | 2007-03-26 | 2008-03-14 | 255d? | finish no earlier than 2008-03-15 | C1; C3 | 4080h | 4080h | PktCbl-Intw | 18 | Cablelabs | D.Hancock@CableLabs.com | Rel-8 | 35 | Frederic |  |  |
| 6710 | 2140.3 | **IMS Enhancements for Security Requirements in Support of Cable Deployments** | 388d? | 2006-12-06 A | 2008-05-30 A | 100% | 2006-12-06 | 2008-05-30 | 388d? |  | S3; C1; C3; C4 | 21024h | 21024h | PktCbl-Sec | 18 | Cablelabs | s.dotson@cablelabs.com | Rel-8 | 34 | Mirko | PktCbl-Sec |  |
| 6711 | 2140.3.1 | SA3 aspects of PktCbl-Sec | 331d? | 2006-12-06 A | 2008-03-12 A | 100% | 2006-12-06 | 2008-03-12 | 331d? | finish no earlier than 2007-12-20 | S3 | 2648h | 2648h | PktCbl-Sec | 18 | Cablelabs | s.dotson@cablelabs.com | Rel-8 | 35 | Mirko |  |  |
| 6712 | 2140.3.2 | CT1 aspects of PktCbl-Sec | 310d? | 2007-03-26 A | 2008-05-30 A | 100% | 2007-03-26 | 2008-05-30 | 310d? | finish no earlier than 2008-06-06 | C1 | 2480h | 2480h | PktCbl-Sec | 18 | Cablelabs | D.Hancock@CableLabs.com | Rel-8 | 35 | Frederic |  |  |
| 6713 | 2140.3.3 | CT3 aspects of PktCbl-Sec | 180d? | 2007-03-26 A | 2007-11-30 A | 100% | 2007-03-26 | 2007-11-30 | 180d? | finish no earlier than 2008-03-15 | C3 | 1440h | 1440h | PktCbl-Sec | 21 | Cablelabs | D.Hancock@CableLabs.com | Rel-8 | 38 | Adrian |  |  |
| 6714 | 2140.3.4 | CT4 aspects of PktCbl-Sec | 255d? | 2007-03-26 A | 2008-03-14 A | 100% | 2007-03-26 | 2008-03-14 | 255d? | finish no earlier than 2008-03-14 | C4 | 2040h | 2040h | PktCbl-Sec | 18 | Cablelabs | D.Hancock@CableLabs.com | Rel-8 | 35 | Kimmo |  |  |
| 6715 | 2141 | **IMS System enhancements for corporate network access** | 1901d? | 2007-06-22 A | 2014-09-12 A | 100% | 2007-06-22 | 2014-12-05 | 1960d? |  | S2; S1; C1; C4; IETF | 91240.9h | 91240.9h | IMS_Corp | 19 | Orange | Delphin Barankanira | Rel-8 | 36 | Maurice | IMS_Corp |  |
| 6716 | 2141.1 | SA1 aspects of IMS_Corp | 23.6d? | 2008-03-12 A | 2008-06-05 A | 100% | 2008-03-12 | 2008-06-05 | 23.6d? | finish no earlier than 2008-06-05 | S1 | 188.8h | 188.8h | IMS_Corp | 21 | Telecom Italia |  | Rel-8 | 39 | Alain |  |  |
| 6717 | 2141.2 | SA2 aspects of IMS_Corp | 325d? | 2007-06-22 A | 2008-09-18 A | 100% | 2007-06-22 | 2008-09-18 | 325d? | finish no earlier than 2008-12-25 | S2 | 2600h | 2600h | IMS_Corp | 19 | Orange | Delphin Barankanira | Rel-8 | 36 | Maurice |  |  |
| 6718 | 2141.3 | CT1 aspects of IMS_Corp | 532d? | 2008-03-07 A | 2010-03-19 A | 100% | 2008-03-07 | 2010-03-19 | 532d? | finish no earlier than 2010-03-19 | C1 | 4244.09h | 4244.09h | IMS_Corp | 21 | Alcatel-Lucent | Keith Drage (drage@alcatel-lucent.com) | Rel-8 | 39 | Frederic |  |  |
| 6719 | 2141.4 | (IETF) CT1 aspects of IMS_Corp (RFC 7316) | 825d? | 2011-06-29 A | 2014-09-12 A | 100% | 2011-06-29 | 2014-12-05 | 885d? | finish no earlier than 2014-09-12 | C1-IETF | 6600h | 6600h | IMS_Corp | 27 | Keith Drage | Keith Drage (drage@alcatel-lucent.com) | Rel-8 | 53 | Frederic |  |  |
| 6720 | 2141.5 | CT4 aspects of IMS_Corp | 196d? | 2008-02-26 A | 2008-12-05 A | 100% | 2008-02-26 | 2008-12-05 | 196d? | finish no earlier than 2008-12-11 | C4 | 1568h | 1568h | IMS_Corp | 21 | Alcatel-Lucent | Keith Drage (drage@alcatel-lucent.com) | Rel-8 | 39 | Kimmo |  |  |
| 6721 | 2142 | **Maintenance of TISPAN documentation** | 1829d? | 2007-07-02 A | 2014-06-13 A | 100% | 2007-07-02 | 2014-06-13 | 1829d? |  | S2; C1; C3; C4; IETF | 85904h | 85904h | MAINTISP | 21 |  |  | Rel-8 | 38 | Maurice | MAINTISP |  |
| 6722 | 2142.1 | Maintenance of TISPAN R2 | 86d? | 2007-11-09 A | 2008-03-07 A | 100% | 2007-11-09 | 2008-03-07 | 86d? | start no earlier than 2007-11-09 | C1; C3; C4 | 2064h | 2064h | MAINT_R2 | 21 | Alcatel-Lucent | Keith Drage (drage@alcatel-lucent.com) | Rel-8 | 38 | Frederic | MAINT_R2 |  |
| 6723 | 2142.2 | Deleted - (IETF) Maintenance of TISPAN R2 (avasarala-dispatch-comm-div-notification) | 1117d? | 2007-11-09 A | 2014-06-13 A | 100% | 2007-11-09 | 2014-06-13 | 1117d? | finish no earlier than 2014-06-13 | C1-IETF | 8936h | 8936h | MAINT_R2_IETF | 27 | Andrew Allen |  | Rel-8 | 52 | Frederic | MAINT_R2_IETF | SP-69 |
| 6724 | 2142.3 | Documentation of TISPAN NGN R1 and R2 in 3GPP SA2 | 104d? | 2008-01-14 A | 2008-06-05 A | 100% | 2008-01-14 | 2008-06-05 | 104d? | finish no earlier than 2008-06-20 | S2 | 832h | 832h | IMS_Comm_Doc | 21 | Nokia Siemens Networks | jozsef.varga@nsn.com | Rel-8 | 38 | Maurice | IMS_Comm_Doc |  |
| 6725 | 2142.4 | Maintenance of TISPAN release 2 common IMS | 114d? | 2007-07-02 A | 2007-12-06 A | 100% | 2007-07-02 | 2007-12-06 | 114d? | finish no earlier than 2007-12-06 | S2 | 912h | 912h | IMS_Comm_Mtce8 | 21 | Telecom Italia | antonio.ascolese@telecomitalia.it | Rel-8 | 38 | Maurice | IMS_Comm_Mtce8 |  |

Notes:
- 6699: -
- 6700: CP#42 completed / Impacted TSs and TRs: 23.218; 24.141; 24.147; 24.173; 24.229; 24.238; 24.247; 24.604; 24.605; 24.606; 24.607; 24.608; 24.610; 24.611; 24.629; 24.930
- 6701: CP#42 completed / Impacted TSs and TRs: 29.163; 29.212; 29.213; 29.214
- 6702: CP#42 completed / Impacted TSs and TRs: 29.228; 29.229; 29.328; 29.329
- 6703: CP#40 completed
- 6704: CP#40 completed
- 6705: SP#38 completed / Impacted TSs and TRs: 23.228
- 6706: CP#40 completed
- 6707: CP#39 completed
- 6708: SP#37 completed / Impacted TSs and TRs: 23.228
- 6709: CP#39 completed / Impacted TSs and TRs: 24.229
- 6710: CP#40 completed
- 6711: SP#39 completed / Impacted TSs and TRs: 33.203; 33.210; 33.220
- 6712: CP#40 completed / Impacted TSs and TRs: 24.229
- 6713: CP#38 completed / Impacted TSs and TRs: 29.163
- 6714: CP#39 completed / Impacted TSs and TRs: 29.228; 29.229; 23.008
- 6715: CP#47 completed
- 6716: SP#40 completed
- 6717: no Stage 2 impacts / Impacted TSs and TRs: 23.228
- 6718: CP#47 completed / Impacted TSs and TRs: 24.229; 24.503
- 6719: CP#65 completed / Impacted TSs and TRs: RFC 7316 (was draft-vanelburg-dispatch-private-network-ind)
- 6720: CP#42 completed / Impacted TSs and TRs: 29.228; 29.229; 23.003; 23.008; 29.433
- 6721: SP#40 completed
- 6722: CP#39 completed / Impacted TSs and TRs: 24.406; 24.407; 24.410; 24.411; 24.423; 24.430; 24.447; 24.451; 24.454; 24.503; 24.505; 24.508; 24.516; 24.528; 24.529; 29.412; 29.421; 29.433; 29.458; 29.527; 29.624
- 6723: CP#64 Draft removed from 3GPP documentation / Impacted TSs and TRs: draft-avasarala-dispatch-comm-div-notification
- 6724: SP#40 completed / Impacted TSs and TRs: 23.228; 23.204; 23.167
- 6725: SP#38 completed / Impacted TSs and TRs: 23.506; 23.507.23.517; 23.521

| ID | WBS | Task | Type | Duration | Start | Finish | Complete | Baseline start | Baseline finish | Baseline duration | Constraint | Resources | Work | Actual work | Acronym | PCG approved | WI rapporteur name | WI rapporteur e-mail | Release | TSG approved | MCC resp | Acronym_3GU_Export | Impacted TSs and TRs |
| --- | --- | --- | --- | --- | --- | --- | --- | --- | --- | --- | --- | --- | --- | --- | --- | --- | --- | --- | --- | --- | --- | --- | --- |
| 6726 | 2143 | **IMS Service Continuity** |  | 318d? | 2008-03-12 A | 2009-05-29 A | 100% | 2008-03-12 | 2009-05-29 | 318d? |  | S2; S1; C1 | 10712h | 10712h | IMS-Cont | 21 | LG Electronics | JaeSeung SONG (anthonys@lge.com) | Rel-8 | 39 | Maurice | IMS-Cont |  |
| 6727 | 2143.1 | Stage 1 IMS Service Continuity |  | 62d? | 2008-03-12 A | 2008-06-05 A | 100% | 2008-03-12 | 2008-06-05 | 62d? | start no earlier than 2008-03-12 | S1 | 496h | 496h | IMS-Cont | 21 | LG Electronics | JaeSeung SONG (anthonys@lge.com) | Rel-8 | 39 | Alain |  |  |
| 6728 | 2143.2 | Stage 2 IMS Service Continuity |  | 62d? | 2008-03-12 A | 2008-06-05 A | 100% | 2008-03-12 | 2008-06-05 | 62d? | finish no earlier than 2008-06-05 | S2 | 496h | 496h | IMS-Cont | 21 | LG Electronics | JaeSeung SONG (anthonys@lge.com) | Rel-8 | 39 | Maurice |  | 23.237; 23.292 |
| 6729 | 2143.3 | Stage 3 IMS Service Continuity |  | 261d? | 2008-05-30 A | 2009-05-29 A | 100% | 2008-05-30 | 2009-05-29 | 261d? | finish no earlier than 2009-05-29 | C1 | 2088h | 2088h | IMS-Cont | 21 | Huawei | Lili Yang (kadyyang@huawei.com) | Rel-8 | 40 | Frederic |  | 24.237; 24.229; 24.216 |
| 6730 | 2144 | **Security Enhancements for IMS** |  | 643.3d? | 2006-09-19 A | 2009-03-06 A | 100% | 2006-09-19 | 2009-03-06 | 643.3d? |  | S3; C1; C4 | 29847.2h | 29847.2h | IMS-Sec | 19 | Ericsson | Bengt.Sahlin@ericsson.com | Rel-8 | 37 | Mirko | IMS-Sec |  |
| 6731 | 2144.1 | Stage 2 for IMS-Sec |  | 466d? | 2007-03-01 A | 2008-12-11 A | 100% | 2007-03-01 | 2008-12-11 | 466d? | finish no earlier than 2008-12-11 | S3 | 3728h | 3728h | IMS-Sec | 19 | Ericsson | Bengt.Sahlin@ericsson.com | Rel-8 | 36 | Mirko |  | 33.203; 33.141; 33.803 |
| 6732 | 2144.2 | CT1 part of Stage 3 for IMS-Sec |  | 392d? | 2006-09-19 A | 2008-12-05 A | 100% | 2006-09-19 | 2008-12-05 | 392d? | finish no earlier than 2008-12-05 | C1 | 3136h | 3136h | IMS-Sec | 21 | Ericsson |  | Rel-8 | 39 | Frederic |  |  |
| 6733 | 2144.3 | CT4 part of Stage 3 for IMS-Sec |  | 457d? | 2007-06-07 A | 2009-03-06 A | 100% | 2007-06-07 | 2009-03-06 | 457d? | finish no earlier than 2009-03-06 | C4 | 3656h | 3656h | IMS-Sec | 21 | Ericsson |  | Rel-8 | 39 | Kimmo |  |  |
| 6734 | 2144.4 | CT1 part of Network Attachment Subsystem (NASS) Bundled Authentication |  | 343d? | 2007-11-14 A | 2009-03-06 A | 100% | 2007-11-14 | 2009-03-06 | 343d? | finish no earlier than 2009-03-06 | C1 | 2744h | 2744h | NBA | 21 | Alcatel-Lucent | Keith Drage (drage@alcatel-lucent.com) | Rel-8 | 39 | Frederic | NBA | 24.229 |
| 6735 | 2144.5 | CT4 part of Network Attachment Subsystem (NASS) Bundled Authentication |  | 143d? | 2007-11-14 A | 2008-05-30 A | 100% | 2007-11-14 | 2008-05-30 | 143d? | start no earlier than 2007-11-14 | C4 | 1144h | 1144h | NBA-CT4 | 21 | Alcatel-Lucent |  | Rel-8 | 39 | Kimmo | NBA-CT4 | 29.229; 29.228; 23.008 |
| 6736 | 2145 | **IMS initiated and controlled PSS and MBMS User Service** |  | 924d? | 2008-03-12 A | 2011-09-21 A | 100% | 2008-03-12 | 2011-09-21 | 924d? |  | S4; S3; IETF | 28108.8h | 28108.8h | IMS_PSS_MBMS_US | 18 | FT, Ericsson | olle.franceschi@ericsson.com | Rel-8 | 34 | Paolo | IMS_PSS_MBMS_US |  |
| 6737 | 2145.1 | SA4, SA3 part of IMS initiated and controlled PSS and MBMS User Service | milestone | 0d? | 2008-03-12 A | 2008-03-12 A | 100% | 2008-03-12 | 2008-03-12 | 0d? | finish no earlier than 2009-03-12 | S4; S3 |  |  | IMS_PSS_MBMS_US | 18 | FT, Ericsson | olle.franceschi@ericsson.com | Rel-8 | 34 | Paolo |  | 26.234; 26.346; 33.246; New 26.237 |
| 6738 | 2145.2 | (IETF) IMS initiated and controlled PSS and MBMS User Service (RFC 6080) |  | 743.6d? | 2008-03-12 A | 2011-09-21 A | 100% | 2008-03-12 | 2011-09-21 | 743.6d? | finish no earlier than 2011-09-21 | S4-IETF | 5932.8h | 5932.8h | IMS_PSS_MBMS_US | 27 | Ericsson |  | Rel-8 | 52 | Paolo |  | RFC 6080 (was draft-ietf-sipping-config-framework) |
| 6739 | 2146 | **Multimedia interworking between IMS and CS networks** |  | 836d? | 2005-09-23 A | 2008-12-05 A | 100% | 2005-09-23 | 2008-12-05 | 836d? |  | C3; C4 | 22800h | 22800h | MIW-IMS | 36 | Vodafone | nico.gabriele@vodafone.com | Rel-8 | 71 | Adrian | MIW-IMS |  |
| 6740 | 2146.1 | Stage 1 and 2 defined in earlier Releases |  | 49d? | 2005-09-23 A | 2005-11-30 A | 100% | 2005-09-23 | 2005-11-30 | 49d? | start no earlier than 2005-09-23 | S2 | 392h | 392h | MIW-IMS | 36 | Vodafone | nico.gabriele@vodafone.com | Rel-8 | 70 | Maurice |  |  |
| 6741 | 2146.2 | Stage 3 of MW-IMS |  | 571d? | 2005-09-23 A | 2007-11-30 A | 100% | 2005-09-23 | 2007-11-30 | 571d? | finish no earlier than 2007-09-14 | C3 | 4568h | 4568h | MIW-IMS-St3C3 | 36 | Vodafone | nico.gabriele@vodafone.com | Rel-8 | 70 | Adrian | MIW-IMS-St3 | 29.863; 29.163 |
| 6742 | 2146.3 | Stage 3 for MW-IMS, MONA extension |  | 285d? | 2007-11-05 A | 2008-12-05 A | 100% | 2007-11-05 | 2008-12-05 | 285d? | finish no earlier than 2008-12-05 | C3 | 2280h | 2280h | MIW-IMS-St3C3_MONA | 21 | Vodafone | Christer.Holmberg@ericsson.com | Rel-8 | 38 | Adrian |  | 29.863; 29.163 |
| 6743 | 2146.4 | Mn interface (MGCF – IM MGW) |  | 273d? | 2007-11-21 A | 2008-12-05 A | 100% | 2007-11-21 | 2008-12-05 | 273d? | finish no earlier than 2008-12-19 | C4 | 2184h | 2184h | MIW-IMS-St3C4 | 21 | Vodafone | Christer.Holmberg@ericsson.com | Rel-8 | 38 | Kimmo |  | 29.332 |
| 6744 | 2147 | **IMS Stage 3 IETF Protocol Alignment - phase 2** |  | 1965d? | 2007-06-22 A | 2014-12-09 A | 100% | 2007-06-22 | 2014-12-05 | 1960d? |  | C1; IETF | 55368h | 55368h | IMSProtoc2 | 19 | Alcatel-Lucent | Keith Drage (drage@alcatel-lucent.com) | Rel-8 | 36 | Frederic | IMSProtoc2 |  |
| 6745 | 2147.1 | CT1 aspects of IMS Stage 3 IETF Protocol Alignment - phase 2 |  | 446d? | 2007-06-22 A | 2009-03-06 A | 100% | 2007-06-22 | 2009-03-06 | 446d? | finish no earlier than 2009-03-06 | C1 | 3568h | 3568h | IMSProtoc2 | 19 | Alcatel-Lucent | Keith Drage (drage@alcatel-lucent.com) | Rel-8 | 36 | Frederic |  | 23.218; 24.229; 24.930 |
| 6746 | 2147.2 | (IETF) IMS Stage 3 IETF Protocol Alignment (draft-bakker-sipping-3gpp-ims-xml-body-handling) |  | 715d? | 2007-06-22 A | 2012-12-07 A | 100% | 2007-06-22 | 2012-12-07 | 715d? | finish no earlier than 2012-12-07 | C1-IETF | 5720h | 5720h | IMSProtoc2 | 27 | Andrew Allen |  | Rel-8 | 52 | Frederic |  | draft-bakker-sipping-3gpp-ims-xml-body-handling |
| 6747 | 2147.3 | (IETF) IMS Stage 3 IETF Protocol Alignment (RFC 6544) |  | 587d? | 2007-06-22 A | 2012-06-15 A | 100% | 2007-06-22 | 2012-06-15 | 587d? | finish no earlier than 2012-04-20 | C1-IETF | 4688h | 4688h | IMSProtoc2 | 27 | Keith Drage |  | Rel-8 | 52 | Frederic |  | RFC 6544 (was draft-ietf-mmusic-ice-tcp) |
| 6748 | 2147.4 | (IETF) IMS Stage 3 IETF Protocol Alignment (draft-ietf-salud-alert-info-urns) |  | 1244d? | 2007-06-22 A | 2014-12-09 A | 100% | 2007-06-22 | 2014-12-05 | 1242d? | finish no earlier than 2014-12-09 | C1-IETF | 9952h | 9952h | IMSProtoc2 | 27 | Roland Jesske | Roland Jesske | Rel-8 | 52 | Frederic |  | draft-ietf-salud-alert-info-urns; RFC 7462 |
| 6749 | 2148 | **Interworking between User-to-User Signalling (UUS) and SIP** |  | 1850d? | 2007-11-30 A | 2014-12-09 A | 100% | 2007-11-30 | 2014-12-05 | 1845d? |  | C1; C3; IETF | 68624.4h | 68624.4h | UUSIW | 21 | Huawei | Lili Yang (kadyyang@huawei.com) | Rel-8 | 38 | Kimmo | UUSIW |  |
| 6750 | 2148.1 | CT1 part of Stage 3 MGCF UUSIW |  | 266d? | 2007-11-30 A | 2008-12-05 A | 100% | 2007-11-30 | 2008-12-05 | 266d? | finish no earlier than 2008-12-05 | C1 | 2128h | 2128h | UUSIW | 21 | Huawei | Lili Yang (kadyyang@huawei.com) | Rel-8 | 38 | Frederic |  | 24.279; 24.229 |
| 6751 | 2148.2 | (IETF) Stage 3 MGCF UUSIW (cuss-sip-uui) |  | 227.03d? | 2007-11-30 A | 2014-12-09 A | 100% | 2007-11-30 | 2014-12-05 | 225.03d? | finish no earlier than 2014-12-09 | C1-IETF; C3-IETF | 3632.4h | 3632.4h | UUSIW | 27 | Roland Jesske | Roland Jesske | Rel-8 | 52 | Frederic |  | RFC 7433 |
| 6752 | 2148.3 | (IETF) Stage 3 MGCF UUSIW (cuss-sip-uui-isdn) |  | 986.5d? | 2011-03-17 A | 2014-12-09 A | 100% | 2011-03-17 | 2014-12-05 | 984.5d? | finish no earlier than 2014-12-09 | C1-IETF; C3-IETF | 15784h | 15784h | UUSIW | 28 | Keith Drage | Keith Drage (drage@alcatel-lucent.com) | Rel-8 | 55 | Frederic |  | RFC 7434 |
| 6753 | 2148.4 | CT3 part of Stage 3 MGCF UUSIW |  | 335d? | 2007-11-30 A | 2009-03-12 A | 100% | 2007-11-30 | 2009-03-12 | 335d? | finish no earlier than 2009-03-12 | C3 | 2680h | 2680h | UUSIW | 21 | Huawei | Lili Yang (kadyyang@huawei.com) | Rel-8 | 38 | Adrian |  | 29.163 |

Notes:
- 6726: CP#44 completed
- 6727: SP#40 completed
- 6728: SP#40 completed
- 6729: CP#44 completed
- 6730: CP#43 completed
- 6731: SP#42 completed. SP#46 withdrawn draft 33.178-100 and 33.978 from Rel-8 onwards
- 6732: CP#42 completed
- 6733: CP#43 completed
- 6734: CP#43 completed
- 6735: CP#40 completed
- 6736: SP#39 WID approved
- 6737: SP#43 completed
- 6738: SP#53/IETF#81 completed
- 6739: CP#42 completed
- 6740: SP#31 Moved from FS section Feb 2006
- 6741: Moved from Rel-7. Feature extended in Rel-8 by including Stage 3 covering MONA UID_380021
- 6742: CP#42 completed
- 6743: CP#42 completed
- 6744: CP#43 completed
- 6745: CP#43 completed
- 6746: CP#58 completed. ietf-draft discontinued. Documented within 3GPP
- 6747: CP#56 completed
- 6748: In RFC Editors Queue. Dec.14: 75->90¦7/3/16: 90%->100; 9/4/21: RFC 7462 added;
- 6749: CP#43 completed
- 6750: CP#42 completed
- 6751: In RFC Editors Queue. Mar15: 90->100%. RFC updated (was draft-ietf-cuss-sip-uui). June 2015: RFC 7433 (was draft-ietf-cuss-sip-uui)
- 6752: In RFC Editors Queue. Dec.14: 75->90. Mar15: 90->100%. RFC updated (was draft-ietf-cuss-sip-uui-isdn). June 2015: RFC 7434 (was draft-ietf-cuss-sip-uui-isdn)
- 6753: CP#43 completed

| ID | WBS | Task | Type | Duration | Start | Finish | Complete | Baseline start | Baseline finish | Baseline duration | Constraint | Resources | Work | Actual work | Acronym | PCG approved | WI rapporteur name | WI rapporteur e-mail | Release | TSG approved | MCC resp | Acronym_3GU_Export | Impacted TSs and TRs | Special Focus Doc | Status Report |
| --- | --- | --- | --- | --- | --- | --- | --- | --- | --- | --- | --- | --- | --- | --- | --- | --- | --- | --- | --- | --- | --- | --- | --- | --- | --- |
| 6754 | 2149 | **Support of Overlap signalling** |  | 331d? | 2007-11-30 A | 2009-03-06 A | 100% | 2007-11-30 | 2009-03-06 | 331d? |  | C3; C1; C4 | 15304.2h | 15304.2h | Overlap | 21 | Deutsche Telekom | r.jesske@telekom.de | Rel-8 | 38 | Adrian | Overlap |  |  |  |
| 6755 | 2149.1 | Stage 3 Overlap (CT1) |  | 331d? | 2007-11-30 A | 2009-03-06 A | 100% | 2007-11-30 | 2009-03-06 | 331d? | finish no earlier than 2009-03-06 | C1 | 2648h | 2648h | Overlap | 21 | Deutsche Telekom | r.jesske@telekom.de | Rel-8 | 38 | Frederic |  | 24.229 |  |  |
| 6756 | 2149.2 | Stage 3 Overlap (CT3) |  | 331d? | 2007-11-30 A | 2009-03-06 A | 100% | 2007-11-30 | 2009-03-06 | 331d? | finish no earlier than 2009-03-06 | C3 | 2648h | 2648h | Overlap | 21 | Deutsche Telekom | r.jesske@telekom.de | Rel-8 | 38 | Adrian |  | 29.163 |  |  |
| 6757 | 2149.3 | Stage 3 Overlap (CT4) |  | 258.02d? | 2007-11-30 A | 2008-12-05 A | 100% | 2007-11-30 | 2008-12-05 | 258.02d? | start no earlier than 2007-11-30 | C4 | 2064.16h | 2064.16h | Overlap | 21 | Deutsche Telekom | r.jesske@telekom.de | Rel-8 | 38 | Kimmo |  | 29.228; 29.229 |  |  |
| 6758 | 2150 | **AS/MRFC Stage 2 and 3** |  | 1203d? | 2007-11-14 A | 2012-06-15 A | 100% | 2007-11-14 | 2012-06-15 | 1203d? |  | C1; IETF | 28384h | 28384h | MRFC_TS | 21 | Hewlett-Packard | mark.syrett@hp.com | Rel-8 | 38 | Frederic | MRFC_TS |  |  |  |
| 6759 | 2150.1 | AS/MRFC Stage 2 |  | 278d? | 2007-11-14 A | 2008-12-05 A | 100% | 2007-11-14 | 2008-12-05 | 278d? | finish no earlier than 2008-12-05 | C1 | 2224h | 2224h | MRFC_TS | 21 | Hewlett-Packard | mark.syrett@hp.com | Rel-8 | 38 | Frederic |  | 23.218 |  |  |
| 6760 | 2150.2 | AS/MRFC Stage 3 |  | 278d? | 2007-11-14 A | 2008-12-05 A | 100% | 2007-11-14 | 2008-12-05 | 278d? | finish no earlier than 2008-12-05 | C1 | 2224h | 2224h | MRFC_TS | 21 | Hewlett-Packard | mark.syrett@hp.com | Rel-8 | 38 | Frederic |  | 24.229; 24.147; 24.247 |  |  |
| 6761 | 2150.3 | (IETF) AS/MRFC Stage 2 and 3 (RFC 6505) |  | 590d? | 2007-11-14 A | 2012-06-15 A | 100% | 2007-11-14 | 2012-06-15 | 590d? | finish no earlier than 2012-06-15 | C1-IETF | 4688h | 4688h | MRFC_TS | 27 | Keith Drage |  | Rel-8 | 52 | Frederic |  | RFC 6505 (was draft-ietf-mediactrl-mixer-control-package) |  |  |
| 6762 | 2151 | **IMS Restoration Procedures** |  | 201d? | 2008-05-30 A | 2009-03-06 A | 100% | 2008-05-30 | 2009-03-06 | 201d? |  | C4; C1 | 6432h | 6432h | IMS_RP | 21 | Ericsson | german.blanco@ericsson.com | Rel-8 | 40 | Kimmo | IMS_RP |  |  |  |
| 6763 | 2151.1 | IMS Restoration Procedures (CT4) |  | 201d? | 2008-05-30 A | 2009-03-06 A | 100% | 2008-05-30 | 2009-03-06 | 201d? | finish no earlier than 2009-03-06 | C4 | 1608h | 1608h | IMS_RP | 21 | Ericsson | german.blanco@ericsson.com | Rel-8 | 40 | Kimmo |  | 23.380; 29.228; 29.229; 29.230; 23.008 |  |  |
| 6764 | 2151.2 | IMS Restoration Procedures (CT1) |  | 201d? | 2008-05-30 A | 2009-03-06 A | 100% | 2008-05-30 | 2009-03-06 | 201d? | finish no earlier than 2009-03-06 | C1 | 1608h | 1608h | IMS_RP | 21 | Ericsson | german.blanco@ericsson.com | Rel-8 | 40 | Frederic |  | 24.229 |  |  |
| 6765 | 2152 | IMS Application Server Service Data Descriptions for AS interoperability |  | 125d? | 2008-09-12 A | 2009-03-06 A | 100% | 2008-09-12 | 2009-03-06 | 125d? | finish no earlier than 2009-03-06 | C4 | 1000h | 1000h | IMS_ASIO | 21 | Alcatel-Lucent | nhberry@alcatel-lucent.com | Rel-8 | 41 | Kimmo | IMS_ASIO | 29.328; 29.329; 29.364 |  |  |
| 6766 | 2153 | **I-WLAN Network Selection Principle (NSP)** |  | 451d? | 2007-06-14 A | 2009-03-06 A | 100% | 2007-06-14 | 2009-03-06 | 451d? |  | S1; C1; C6 | 13859.2h | 13859.2h | IWLANNSP | 18 | Telefónica O2 | chris.friel@O2.com | Rel-8 | 34 | Alain | IWLANNSP |  | WLAN |  |
| 6767 | 2153.1 | Stage 1 for I-WLAN NSP | milestone | 0d? | 2007-06-14 A | 2007-06-14 A | 100% | 2007-06-14 | 2007-06-14 | 0d? |  | S1 |  |  | IWLANNSP | 21 | Telefónica O2 | chris.friel@O2.com | Rel-8 | 39 | Alain |  | 22.234 | WLAN |  |
| 6768 | 2153.2 | CT1 part of Stage 3 for I-WLAN NSP |  | 261d? | 2008-03-07 A | 2009-03-06 A | 100% | 2008-03-07 | 2009-03-06 | 261d? | finish no earlier than 2008-12-05 | C1 | 2088h | 2088h | IWLANNSP | 21 | Research In Motion | Adrian Buckley (abuckley@rim.com) | Rel-8 | 39 | Frederic |  | 24.234 | WLAN |  |
| 6769 | 2153.3 | CT6 part of Stage 3 for I-WLAN NSP |  | 118.4d? | 2008-03-07 A | 2008-12-11 A | 100% | 2008-03-07 | 2008-12-11 | 118.4d? | finish no earlier than 2008-12-11 | C6 | 947.2h | 947.2h | IWLANNSP | 21 | Research In Motion | Adrian Buckley (abuckley@rim.com) | Rel-8 | 39 | Xavier |  | 31.102; 31.111 | WLAN |  |
| 6770 | 2154 | **Mobility between 3GPP-WLAN Interworking and 3GPP Systems** |  | 386d? | 2007-09-14 A | 2009-03-06 A | 100% | 2007-09-14 | 2009-03-06 | 386d? |  | S2; C1 | 9304h | 9304h | IWLAN_Mob | 19 | Orange | xiaobao.chen@orange-ftgroup.com | Rel-8 | 37 | Maurice | IWLAN_Mob |  | WLAN |  |
| 6771 | 2154.1 | Stage 2 for Mobility between 3GPP-WLAN Interworking and 3GPP Systems |  | 190d? | 2007-09-14 A | 2008-06-05 A | 100% | 2007-09-14 | 2008-06-05 | 190d? | finish no earlier than 2008-09-08 | S2 | 1520h | 1520h | IWLAN_Mob | 21 | Orange | xiaobao.chen@orange-ftgroup.com | Rel-8 | 38 | Maurice |  | new 23.327 | WLAN |  |
| 6772 | 2154.2 | CT1 aspects of Mobility between 3GPP-WLAN Interworking and 3GPP Systems |  | 201d? | 2008-05-30 A | 2009-03-06 A | 100% | 2008-05-30 | 2009-03-06 | 201d? | finish no earlier than 2009-03-06 | C1 | 1608h | 1608h | IWLAN_Mob | 21 | Orange | reina.nader@orange-ftgroup.com | Rel-8 | 40 | Frederic |  | 24.303; new 24.327 | WLAN |  |
| 6773 | 2155 | Conformance Test Aspects – Mobility between 3GPP WLAN Interworking and 3GPP Systems |  | 206d? | 2009-12-04 A | 2010-09-17 A | 100% | 2009-12-04 | 2010-09-17 | 206d? | finish no earlier than 2010-09-17 | R5 | 1648h | 1648h | IWLAN_Mob_UEConTest | 24 | Qualcomm | Patrick Stupar (pstupar@qualcomm.com) | Rel-8 | 46 | Ingbert | IWLAN_Mob_UEConTest | 34.108; 34.123-1; 34.123-2; 34.123-3 | WLAN | RP-100740 |
| 6774 | 2156 | **Enhancements for Voice Group Call Service (VGCS) Applications (EVA)** |  | 919d? | 2006-03-15 A | 2009-09-18 A | 100% | 2006-03-15 | 2009-09-18 | 919d? |  | S1; C1; C4; G2 | 45559.5h | 45559.5h | EVA | 36 | Nortel | Amar Deol (deola@nortelnetworks.com) | Rel-8 | 70 | Alain | EVA |  |  |  |
| 6775 | 2156.1 | SA1 aspects of EVA |  | 191d? | 2006-03-15 A | 2006-12-06 A | 100% | 2006-03-15 | 2006-12-06 | 191d? | finish no earlier than 2006-12-06 | S1 | 1528h | 1528h | EVA | 17 | Nortel | Amar Deol (deola@nortelnetworks.com) | Rel-8 | 32 | Alain |  | 42.068 |  |  |
| 6776 | 2156.2 | VGCS/VBS and GPRS Interactions |  | 145d? | 2007-09-03 A | 2008-03-21 A | 100% | 2007-09-03 | 2008-03-21 | 145d? | finish no earlier than 2008-03-21 | S1 | 1160h | 1160h | EVA | 19 | Huawei | Ling Liu | Rel-8 | 37 | Alain |  | 42.068; 42.069 |  |  |
| 6777 | 2156.3 | CT1 aspects of EVA |  | 862d? | 2006-06-02 A | 2009-09-18 A | 100% | 2006-06-02 | 2009-09-18 | 862d? | finish no earlier than 2009-12-04 | C1 | 6887.53h | 6887.53h | EVA | 17 | Nortel | milanpa@nortel.com | Rel-8 | 32 | Frederic |  | 43.068; 44.068 |  |  |
| 6778 | 2156.4 | CT4 aspects of EVA |  | 391d? | 2006-06-02 A | 2007-11-30 A | 100% | 2006-06-02 | 2007-11-30 | 391d? | finish no earlier than 2007-06-01 | C4 | 3128h | 3128h | EVA | 17 | Nortel |  | Rel-8 | 32 | Kimmo |  | 29.002 |  |  |
| 6779 | 2156.5 | GERAN2 aspects of EVA |  | 431d? | 2006-06-30 A | 2008-02-22 A | 100% | 2006-06-30 | 2008-02-22 | 431d? | finish no earlier than 2008-02-22 | G2 | 3448h | 3448h | EVA |  | Nortel | frank.billenkamp@nortel.com | Rel-8 |  | Gert |  | 44.018; 48.008 |  |  |

Notes:
- 6754: CP#43 completed
- 6755: CP#43 completed
- 6756: CP#43 completed
- 6757: CP#42 completed
- 6758: Triggered by Study UID_7048 (MRFC)
- 6759: CP#42 completed
- 6760: CP#42 completed
- 6761: CP#56 completed
- 6762: CP#43 completed. Triggered by Study TR 23.820 (FS_IMS_RP) UID_350018
- 6763: CP#43 completed
- 6764: CP#43 completed
- 6765: CP#43 completed. Triggered by UID_360030 (FS_IMS_ASIO)
- 6766: CP#43 completed
- 6767: SP#36 completed
- 6768: CP#43 completed
- 6769: CP#42 completed
- 6770: CP#43 completed
- 6771: SP#40 completed
- 6772: CP#43 completed
- 6773: RP#49 completed. Testing for Rel-8 UID_400013 CT1 aspects of mobility between 3GPP WLAN Interworking and 3GPP Systems (24.327)
- 6774: CP#45 completed
- 6775: SP#38 completed
- 6776: SP#39 completed
- 6777: CP#45 completed
- 6778: CP#38 completed
- 6779: GP#37 completed

| ID | WBS | Task | Type | Duration | Start | Finish | Complete | Baseline start | Baseline finish | Baseline duration | Constraint | Resources | Work | Actual work | Acronym | WI rapporteur name | WI rapporteur e-mail | Release | MCC resp | Acronym_3GU_Export | Impacted TSs and TRs | TSG stopped | Special Focus Doc | TSG approved | PCG approved | Status Report |
| --- | --- | --- | --- | --- | --- | --- | --- | --- | --- | --- | --- | --- | --- | --- | --- | --- | --- | --- | --- | --- | --- | --- | --- | --- | --- | --- |
| 6780 | 2157 | **Personal Network Management** |  | 955d? | 2005-07-11 A | 2009-03-06 A | 100% | 2005-07-11 | 2009-03-06 | 955d? |  | S1; C1; S3 | 46368h | 46368h | PNM | Vodafone | armin.toepfer@vodafone.com | Rel-8 | Alain | PNM |  |  |  |  |  |  |
| 6781 | 2157.1 | Stage 1 for PNM |  | 276d? | 2005-07-11 A | 2006-07-31 A | 100% | 2005-07-11 | 2006-07-31 | 276d? | start no earlier than 2005-07-11 | S1 | 2208h | 2208h | PNM | Vodafone | armin.toepfer@vodafone.com | Rel-8 | Alain |  | 22.259 |  |  |  |  |  |
| 6782 | 2157.2 | Stage 2 for PNM |  | 445d? | 2007-03-26 A | 2008-12-05 A | 100% | 2007-03-26 | 2008-12-05 | 445d? | finish no earlier than 2008-12-05 | C1 | 3560h | 3560h | PNM | Vodafone | yang.lu@vodafone.com | Rel-8 | Frederic |  | 23.259 |  |  |  |  |  |
| 6783 | 2157.3 | **Stage 3 for PNM** |  | 510d? | 2007-03-26 A | 2009-03-06 A | 100% | 2007-03-26 | 2009-03-06 | 510d? |  | C1; C4 | 15800h | 15800h | PNM | Vodafone | yang.lu@vodafone.com | Rel-8 | Frederic |  |  |  |  |  |  |  |
| 6784 | 2157.3.1 | CT1 aspects of Stage 3 PNM |  | 510d? | 2007-03-26 A | 2009-03-06 A | 100% | 2007-03-26 | 2009-03-06 | 510d? | finish no earlier than 2008-12-05 | C1 | 4080h | 4080h | PNM | Vodafone | yang.lu@vodafone.com | Rel-8 | Frederic |  | 24.259; 24.229 |  |  |  |  |  |
| 6785 | 2157.3.2 | Deleted - CT4 aspects of Stage 3 PNM |  | 445d? | 2007-03-26 A | 2008-12-05 A | 100% | 2007-03-26 | 2008-12-05 | 445d? | finish no earlier than 2008-12-11 | C4 | 3560h | 3560h | PNM | Vodafone | yang.lu@vodafone.com | Rel-8 | Kimmo |  |  | CP-42 |  |  |  |  |
| 6786 | 2157.4 | Key establishment between a UICC hosting device and a remote device |  | 235d? | 2006-12-06 A | 2007-10-30 A | 100% | 2006-12-06 | 2007-10-30 | 235d? | finish no earlier than 2007-10-30 | S3 | 1880h | 1880h | PNM | Ericsson | Vesa.Lehtovirta@ericsson.com | Rel-8 | Mirko |  | 33.259 |  |  |  |  |  |
| 6787 | 2157.5 | Deleted - Actual Requirements of PNM | milestone | 0d? | 2007-03-26 A | 2007-03-26 A | 100% | 2007-03-26 | 2007-03-26 | 0d? | finish no earlier than 2007-03-26 | C1 |  |  | PNM | Ericsson |  | Rel-8 | Frederic |  |  | SP-37 |  |  |  |  |
| 6788 | 2158 | **eCall Data Transfer** |  | 637d? | 2006-09-28 A | 2009-03-06 A | 100% | 2006-09-28 | 2009-03-06 | 637d? |  | S1; C1 | 14840h | 14840h | EData | Airbiquity | rrobinson@airbiquity.com | Rel-8 | Alain | EData |  |  | Public Safety (I-A) |  |  |  |
| 6789 | 2158.1 | eData Requirements |  | 380d? | 2006-09-28 A | 2008-03-12 A | 100% | 2006-09-28 | 2008-03-12 | 380d? | finish no earlier than 2006-12-07 | S1 | 3040h | 3040h | EData | Airbiquity | rrobinson@airbiquity.com | Rel-8 | Alain |  | 22.101; 22.105 |  | Public Safety (I-A) | 37 |  |  |
| 6790 | 2158.2 | Transfer of data during an emergency call |  | 201d? | 2008-05-30 A | 2009-03-06 A | 100% | 2008-05-30 | 2009-03-06 | 201d? | finish no earlier than 2009-03-06 | C1 | 1608h | 1608h | EData | T-Mobile | Dieter Jacobsohn | Rel-8 | Frederic |  | 24.008 |  | Public Safety (I-A) | 40 | 21 |  |
| 6791 | 2159 | eCall data transfer Phase 2: Comparison of alternative in-band modem solutions and standardization of one in-band modem solution |  | 472d? | 2007-12-06 A | 2009-09-24 A | 100% | 2007-12-06 | 2009-09-24 | 472d? | finish no earlier than 2009-09-24 | S4 | 3768.09h | 3768.09h | eCall_Phase2 | Airbiquity | lhong@airbiquity.com & rrobinson@airbiquity.com | Rel-8 | Paolo | eCall_Phase2 | 26.267; 26.268; 26.269; 26.967; 26.969 |  | Public Safety (I-A) |  |  |  |
| 6792 | 2160 | eCall Conformance Testing |  | 261d? | 2009-09-04 A | 2010-09-03 A | 100% | 2009-09-04 | 2010-09-03 | 261d? | finish no earlier than 2010-09-03 | G3new | 2088h | 2088h | eCall_MSTest | Ericsson, Qualcomm | Vikrant Jain (vikrantj@qualcomm.com) | Rel-8 | Ingbert | eCall_MSTest | 51.010-1; 51.010-2 |  | Public Safety (I-A) | 45 | 23 |  |
| 6793 | 2161 | Conformance Test Aspects – non-modem procedures of eCall sessions in UTRA |  | 186d? | 2009-09-18 A | 2010-06-04 A | 100% | 2009-09-18 | 2010-06-04 | 186d? | finish no earlier than 2010-06-04 | R5 | 1488h | 1488h | UMTS_eCall_UEConTest | Ericsson, Qualcomm | Shubhang Vora (svora@qualcomm.com) | Rel-8 | Ingbert | UMTS_eCall_UEConTest | 34.108; 34.123-1; 34.123-2; 34.123-3 |  | Public Safety (I-A) | 45 | 23 | RP-100489 |
| 6794 | 2162 | **IP Interconnection of Services** |  | 668d? | 2006-08-16 A | 2009-03-06 A | 100% | 2006-08-16 | 2009-03-06 | 668d? |  | S1; S2; S5; C3 | 44240h | 44240h | IPinterc | Telefónica O2 | chris.friel@O2.com | Rel-8 | Alain | IPinterc |  |  |  | 38 | 21 |  |
| 6795 | 2162.1 | Stage 1 for IPinterc |  | 70d? | 2007-12-06 A | 2008-03-12 A | 100% | 2007-12-06 | 2008-03-12 | 70d? | start no earlier than 2007-12-06 | S1 | 560h | 560h | IPinterc | Telefónica O2 | chris.friel@O2.com | Rel-8 | Alain |  | 22.101; 22.228 |  |  | 38 | 21 |  |
| 6796 | 2162.2 | **System enhancements for interconnection interfaces between two IMSs** |  | 668d? | 2006-08-16 A | 2009-03-06 A | 100% | 2006-08-16 | 2009-03-06 | 668d? |  | S2; S5; C3 | 22304h | 22304h | IMS_NNI | Telecom Italia | Mario Madella (mario.madella@telecomitalia.it) | Rel-8 | Maurice | IMS_NNI |  |  |  |  |  |  |
| 6797 | 2162.2.1 | Stage 2 for IMS_NNI |  | 120d? | 2007-06-22 A | 2007-12-06 A | 100% | 2007-06-22 | 2007-12-06 | 120d? | finish no earlier than 2007-12-21 | S2 | 960h | 960h | IMS_NNI | Telecom Italia | Mario Madella (mario.madella@telecomitalia.it) | Rel-8 | Maurice |  | 23.002; 23.228 |  |  |  |  |  |
| 6798 | 2162.2.2 | IMS inter-operator service interconnection interface |  | 461d? | 2007-06-01 A | 2009-03-06 A | 100% | 2007-06-01 | 2009-03-06 | 461d? | finish no earlier than 2009-03-06 | C3 | 3688h | 3688h | FBI2-IOPSI | Telecom Italia | antonio.ascolese@telecomitalia.it | Rel-8 | Adrian | FBI2-IOPSI | 29.865; 29.165 |  |  |  |  |  |
| 6799 | 2162.2.3 | Charging harmonization for NGN between 3GPP and ATIS-TMOC |  | 51d? | 2006-09-28 A | 2006-12-07 A | 100% | 2006-09-28 | 2006-12-07 | 51d? | finish no earlier than 2006-12-07 | S5 | 408h | 408h | FBI2-TISP2-CH | Amdocs | yishai.brown@amdocs.com | Rel-8 | Mirko | FBI2-TISP2-CH | 32.297 |  |  |  |  |  |
| 6800 | 2162.2.4 | Deleted - Protocol impact of FBI for TISPAN R2 |  | 152d? | 2006-08-16 A | 2007-03-15 A | 100% | 2006-08-16 | 2007-03-15 | 152d? | finish no earlier than 2007-03-15 | C1 | 1216h | 1216h | FBI2-TISP2-c1 | Ericsson |  | Rel-8 | Frederic | FBI2-TISP2-c1 |  | SP-38 |  |  |  |  |
| 6801 | 2162.2.5 | Deleted (never approved) - Stage 2 of FBI for TISPAN R2 - Rel 8 | milestone | 0d? | 2007-11-30 A | 2007-11-30 A | 100% | 2007-11-30 | 2007-11-30 | 0d? | finish no earlier than 2007-11-30 | S2 |  |  | FBI2-TISP2-s2 | Nokia Siemens Networks |  | Rel-8 | Maurice | FBI2-TISP2-s2 |  | SP-36 |  |  |  |  |
| 6802 | 2163 | **Support of (G)MSC-S – (G)MSC-S Nc Interface based on the SIP-I protocol** |  | 386d? | 2007-09-14 A | 2009-03-06 A | 100% | 2007-09-14 | 2009-03-06 | 386d? |  | C4; C3 | 14960h | 14960h | SIP_Nc | Vodafone | David.Hutton@vodafone.com | Rel-8 | Kimmo | SIP_Nc |  |  |  |  |  |  |
| 6803 | 2163.1 | Stage 1 for SIP_Nc (covered by Feature IPinterc) |  | 70d? | 2007-12-06 A | 2008-03-12 A | 100% | 2007-12-06 | 2008-03-12 | 70d? | start no earlier than 2007-12-06 | S1 | 560h | 560h | SIP_Nc | Telefónica O2 | chris.friel@O2.com | Rel-8 | Alain |  | 22.101; 22.228 |  |  | 41 | 21 |  |
| 6804 | 2163.2 | SIP-I based circuit-switched core network; Stage 2 |  | 321d? | 2007-09-14 A | 2008-12-05 A | 100% | 2007-09-14 | 2008-12-05 | 321d? | finish no earlier than 2008-12-11 | C4 | 2568h | 2568h | SIP_Nc-St2 | Vodafone | David.Hutton@vodafone.com | Rel-8 | Kimmo | SIP_Nc-St2 | 23.231; 23.153; 23.205 |  |  |  |  |  |
| 6805 | 2163.3 | Application of SIP-I Protocols to Circuit Switched (CS) core network architecture; Stage 3 |  | 321d? | 2007-09-14 A | 2008-12-05 A | 100% | 2007-09-14 | 2008-12-05 | 321d? | finish no earlier than 2008-12-11 | C4 | 2568h | 2568h | SIP_Nc-St3C4 | Vodafone | David.Hutton@vodafone.com | Rel-8 | Kimmo | SIP_Nc-St3 | 29.231; 29.232; 29.332 |  |  |  |  |  |
| 6806 | 2163.4 | Interworking between the 3GPP CS domain with SIP-I as signalling protocol and other networks |  | 386d? | 2007-09-14 A | 2009-03-06 A | 100% | 2007-09-14 | 2009-03-06 | 386d? | finish no earlier than 2009-03-06 | C3 | 3088h | 3088h | SIP_Nc-St3C3 | Nokia Siemens Networks | Thomas.Belling@nsn.com | Rel-8 | Adrian |  | 29.235; 23.172; 23.202; 29.007; 29.163; 29.414 |  |  |  |  |  |

Notes:
- 6780: CP#43 completed
- 6781: SP#31 completed
- 6782: CP#42 completed
- 6783: CP#43 completed
- 6784: CP#43 completed
- 6785: CP#42 no impact on CT4 specs
- 6786: SP#37 completed
- 6787: SP#37 stopped
- 6788: SP#39 completed. Linked to SA4 Feature UID_34042 (eCall_Phase2)
- 6789: SP#39 completed
- 6790: CP#43 completed
- 6791: SP#45 completed. Triggered by Study UID_360015 (eCALLIBMS). Linked to SA1 Feature UID_330005 (EData)
- 6792: GP#47 completed. GP#43 WID approved. Testing for Rel-8 eCall_Phase2 (UID_34042) and EData (UID_330005)
- 6793: RP#48 completed. Testing for Rel-8 eCall_Phase2 (UID_34042) and Edata (UID_330005)
- 6794: SP#43 completed
- 6795: SP#39 completed.
- 6796: CP#43 completed
- 6797: SP#38 completed
- 6798: CP#43 completed
- 6799: SP#34 completed
- 6800: SP#38 stopped
- 6801: SP#36 stopped
- 6802: CP#43 completed. Stage 1 in Feature UID_380060 (IPinterc). CP#40 updated WID CP-070517=>CP-080282
- 6803: 22/07/08 Created. Stage 1 for SIP_Nc (covered by SA1 Feature UID_380060 Ipinterc)
- 6804: CP#42 completed
- 6805: CP#42 completed
- 6806: CP#43 completed. CP#42 target 12/08=>03/09

| ID | WBS | Task | Type | Duration | Start | Finish | Complete | Baseline start | Baseline finish | Baseline duration | Constraint | Resources | Work | Actual work | Acronym | WI rapporteur name | WI rapporteur e-mail | Release | TSG approved | MCC resp | Special Focus Doc | Acronym_3GU_Export | Impacted TSs and TRs | PCG approved | Status Report |
| --- | --- | --- | --- | --- | --- | --- | --- | --- | --- | --- | --- | --- | --- | --- | --- | --- | --- | --- | --- | --- | --- | --- | --- | --- | --- |
| 6807 | 2164 | **Earthquake and Tsunami Warning System** |  | 440d? | 2007-09-10 A | 2009-05-15 A | 100% | 2007-09-10 | 2009-05-15 | 440d? |  | S1; S2; C1; C4; G2 | 21280h | 21280h | ETWS | NTT DoCoMo | kitaharar@nttdocomo.co.jp | Rel-8 | 37 | Alain | Public Safety (I-A) | ETWS |  |  |  |
| 6808 | 2164.1 | Stage 1 for ETWS |  | 133d? | 2007-09-10 A | 2008-03-12 A | 100% | 2007-09-10 | 2008-03-12 | 133d? | finish no earlier than 2008-03-12 | S1 | 1064h | 1064h | ETWS | NTT DoCoMo | kitaharar@nttdocomo.co.jp | Rel-8 | 37 | Alain | Public Safety (I-A) |  | 22.168 |  |  |
| 6809 | 2164.2 | SA2 aspects of ETWS |  | 179d? | 2008-01-14 A | 2008-09-18 A | 100% | 2008-01-14 | 2008-09-18 | 179d? | finish no earlier than 2008-09-08 | S2 | 1432h | 1432h | ETWS | NTT DoCoMo | tanakai@nttdocomo.co.jp | Rel-8 | 38 | Maurice | Public Safety (I-A) |  | 23.828; 23.401 | 21 |  |
| 6810 | 2164.3 | CT1 aspects of ETWS |  | 50.5d? | 2008-05-30 A | 2008-12-05 A | 100% | 2008-05-30 | 2008-12-05 | 50.5d? | finish no earlier than 2008-12-05 | C1 | 404h | 404h | ETWS | NTT DoCoMo | yamashitahi@s1.nttdocomo.co.jp | Rel-8 | 40 | Frederic | Public Safety (I-A) |  | 23.041 | 21 |  |
| 6811 | 2164.4 | CT4 aspects of ETWS |  | 50.5d? | 2008-09-26 A | 2008-12-05 A | 100% | 2008-09-26 | 2008-12-05 | 50.5d? | finish no earlier than 2008-12-05 | C4 | 404h | 404h | ETWS | NTT DoCoMo | yamashitahi@s1.nttdocomo.co.jp | Rel-8 | 40 | Kimmo | Public Safety (I-A) |  | 29.168 | 21 |  |
| 6812 | 2164.5 | ETWS primary notification message definition in GERAN |  | 47d? | 2009-03-12 A | 2009-05-15 A | 100% | 2009-03-12 | 2009-05-15 | 47d? | finish no earlier than 2009-05-15 | G2 | 376h | 376h | ETWS | Ericsson | claes-goran.persson@ericsson.com | Rel-8 | 43 | Gert | Public Safety (I-A) |  | 44.018; 44.060 | 22 |  |
| 6813 | 2165 | Conformance Test Aspects – UMTS Earthquake and Tsunami Warning System (ETWS) FDD |  | 207d? | 2009-05-29 A | 2010-03-12 A | 100% | 2009-05-29 | 2010-03-12 | 207d? | finish no earlier than 2010-03-12 | R5 | 1656h | 1656h | ETWS_UMTS_UEConTestFDD | NTT DoCoMo | Makoto Ito (itohm@nttdocomo.co.jp) | Rel-8 | 44 | Ingbert | Public Safety (I-A) | ETWS_UMTS_UEConTestFDD | 34.108; 34.123-1; 34.123-2 | 23 | RP-100068 |
| 6814 | 2166 | **In Case of Emergency numbers storage and easy access on UICC** |  | 519d? | 2007-03-13 A | 2009-03-06 A | 100% | 2007-03-13 | 2009-03-06 | 519d? |  | S1; C6 | 14552h | 14552h | ICE | Vodafone | armin.toepfer@vodafone.com | Rel-8 | 38 | Alain |  | ICE |  | 21 |  |
| 6815 | 2166.1 | Stage 1 for ICE |  | 262d? | 2007-03-13 A | 2008-03-12 A | 100% | 2007-03-13 | 2008-03-12 | 262d? | finish no earlier than 2008-03-12 | S1 | 2096h | 2096h | ICE | Vodafone | armin.toepfer@vodafone.com | Rel-8 | 38 | Alain |  |  | 22.030; 22.101 | 21 |  |
| 6816 | 2166.2 | CT6 aspects of ICE |  | 519d? | 2007-03-13 A | 2009-03-06 A | 100% | 2007-03-13 | 2009-03-06 | 519d? | finish no earlier than 2009-03-06 | C6 | 4152h | 4152h | ICE | Vodafone | armin.toepfer@vodafone.com | Rel-8 | 38 | Xavier |  |  | 31.102 | 21 |  |
| 6817 | 2167 | Local Charging Zone Requirements |  | 380d? | 2006-09-28 A | 2008-03-12 A | 100% | 2006-09-28 | 2008-03-12 | 380d? | finish no earlier than 2006-12-07 | S1 | 3040h | 3040h | LCZR | China Mobile | liuhongyfw@chinamobile.com | Rel-8 |  | Alain |  | LCZR | 22.115 |  |  |
| 6818 | 2168 | **Customized Alerting Tone (CAT) service** |  | 729d? | 2006-12-06 A | 2009-09-18 A | 100% | 2006-12-06 | 2009-09-18 | 729d? |  | S1; C1; C3; C4 | 39854h | 39854h | CAT | China Mobile | fenglingjuan@chinamobile.com | Rel-8 | 34 | Alain |  | CAT |  |  |  |
| 6819 | 2168.1 | Stage 1 for CAT |  | 207d? | 2006-12-06 A | 2007-09-20 A | 100% | 2006-12-06 | 2007-09-20 | 207d? | start no earlier than 2006-12-06 | S1 | 1656h | 1656h | CAT | China Mobile | fenglingjuan@chinamobile.com | Rel-8 | 37 | Alain |  |  | 22.182 |  |  |
| 6820 | 2168.2 | TISPAN requirements for customized multimedia information services |  | 71d? | 2007-09-03 A | 2007-12-10 A | 100% | 2007-09-03 | 2007-12-10 | 71d? | finish no earlier than 2007-12-10 | S1 | 568h | 568h | TISCMI | China Mobile | fenglingjuan@chinamobile.com | Rel-8 | 37 | Alain |  | TISCMI | 22.182 |  |  |
| 6821 | 2168.3 | **IMS CAT Supplementary Service** |  | 399d? | 2008-03-12 A | 2009-09-18 A | 100% | 2008-03-12 | 2009-09-18 | 399d? |  | C1; C3 | 10814.4h | 10814.4h | CAT-SS | Nortel | milanpa@nortel.com | Rel-8 | 39 | Frederic |  | CAT-SS |  | 21 |  |
| 6822 | 2168.3.1 | IMS CAT SS |  | 164d? | 2008-04-21 A | 2008-12-04 A | 100% | 2008-04-21 | 2008-12-04 | 164d? | finish no earlier than 2008-12-05 | C1 | 1312h | 1312h | CAT-SS | Nortel | milanpa@nortel.com | Rel-8 | 39 | Frederic |  |  | 24.182 | 21 |  |
| 6823 | 2168.3.2 | CAT solution for voice and video call in CS domain |  | 389.8d? | 2008-03-12 A | 2009-09-18 A | 100% | 2008-03-12 | 2009-09-18 | 389.8d? | finish no earlier than 2009-09-11 | C3 | 3118.4h | 3118.4h | CAT-SS | Nortel | milanpa@nortel.com | Rel-8 | 39 | Adrian |  |  | 29.163 | 21 |  |
| 6824 | 2168.4 | **CAT Service in 3GPP CS domain** |  | 126d? | 2008-09-12 A | 2009-03-06 A | 100% | 2008-09-12 | 2009-03-06 | 126d? |  | C4; C1 | 3487.6h | 3487.6h | CAT-3G_CS | China Mobile | zhaoyuyi@chinamobile.com | Rel-8 | 41 | Kimmo |  | CAT-3G_CS | 23.205; 23.231; 29.002 | 21 |  |
| 6825 | 2168.4.1 | CT4 part of CAT Service in 3GPP CS domain |  | 126d? | 2008-09-12 A | 2009-03-06 A | 100% | 2008-09-12 | 2009-03-06 | 126d? | finish no earlier than 2009-03-06 | C4 | 1008h | 1008h | CAT-3G_CS | China Mobile | zhaoyuyi@chinamobile.com | Rel-8 | 41 | Kimmo |  |  | 23.205; 23.231; 29.002 | 21 |  |
| 6826 | 2168.4.2 | CT1 part of CAT Service in 3GPP CS domain |  | 57.95d? | 2008-09-12 A | 2008-12-05 A | 100% | 2008-09-12 | 2008-12-05 | 57.95d? | start no earlier than 2008-09-12 | C1 | 463.6h | 463.6h | CAT-3G_CS | China Mobile | zhaoyuyi@chinamobile.com | Rel-8 | 41 | Frederic |  |  | 24.008; 23.014 | 21 |  |
| 6827 | 2169 | **Service-Level Interworking for Messaging Services** |  | 509d? | 2007-03-26 A | 2009-03-06 A | 100% | 2007-03-26 | 2009-03-06 | 509d? |  | S1; S2; C3; C1 | 20800h | 20800h | MESSIW | Huawei | ling.liu@huawei.com; duanxiaoqin@huawei.com | Rel-8 | 34 | Alain |  | MESSIW |  |  |  |
| 6828 | 2169.1 | Stage 1 for MESSIW | milestone | 0d? | 2007-03-26 A | 2007-03-26 A | 100% | 2007-03-26 | 2007-03-26 | 0d? | finish no earlier than 2007-12-01 | S1 |  |  | MESSIW | Huawei | ling.liu@huawei.com | Rel-8 |  | Alain |  |  | 22.105; 22.340 |  |  |
| 6829 | 2169.2 | Stage 2 for MESSIW |  | 227d? | 2007-04-26 A | 2008-03-07 A | 100% | 2007-04-26 | 2008-03-07 | 227d? | finish no earlier than 2008-03-07 | S2 | 1816h | 1816h | MESSIW | Huawei | patrice.hede@huawei.com | Rel-8 |  | Maurice |  |  | 23.811; 23.204 |  |  |
| 6830 | 2169.3 | CT3 part of Stage 3 for MESSIW |  | 201d? | 2008-05-30 A | 2009-03-06 A | 100% | 2008-05-30 | 2009-03-06 | 201d? | finish no earlier than 2008-12-05 | C3 | 1608h | 1608h | MESSIW | Huawei | xupeili@huawei.com | Rel-8 | 40 | Adrian |  |  | 29.311 | 21 |  |
| 6831 | 2169.4 | CT1 part of Stage 3 for MESSIW |  | 136d? | 2008-05-30 A | 2008-12-05 A | 100% | 2008-05-30 | 2008-12-05 | 136d? | finish no earlier than 2008-12-12 | C1 | 1088h | 1088h | MESSIW | Huawei | xupeili@huawei.com | Rel-8 | 40 | Frederic |  |  | 24.229 | 21 |  |

Notes:
- 6807: SP#43 Larger scope Feature UID_380057 (PWS) moved to Rel-9
- 6808: SP#39 completed
- 6809: SP#41 completed
- 6810: CP#42 completed
- 6811: CP#42 completed
- 6812: SP#44 completed with CT1 help (GERAN2 LS_in SP-090154)
- 6813: RP#47 completed. Testing for Rel-8 ETWS UID_370051
- 6814: CP#43 completed (ICE Graphics not included in Rel-8)
- 6815: SP#39 Stage 1 completed
- 6816: CP#43 completed (ICE Graphics not in Rel-8 / not explicitly in SA1 WID either)
- 6817: SP#39 Stage 1 completed
- 6818: CP#45 completed
- 6819: -
- 6820: SP#38 completed
- 6821: -
- 6822: CP#42 completed
- 6823: CP#45 completed. Triggered by Study UID_360031 (TR 29.882)
- 6824: -
- 6825: CP#43 completed. Triggered by Study UID_360031 (TR 29.882)
- 6826: CP#42 completed. Triggered by Study UID_360031 (TR 29.882)
- 6827: CP#43 completed
- 6828: SP#35 completed
- 6829: SP#39 completed
- 6830: CP#43 completed
- 6831: CP#42 completed

| ID | WBS | Task | Duration | Start | Finish | Complete | Baseline start | Baseline finish | Baseline duration | Constraint | Resources | Work | Actual work | Acronym | WI rapporteur name | WI rapporteur e-mail | Release | TSG approved | MCC resp | Special Focus Doc | Acronym_3GU_Export | Impacted TSs and TRs | PCG stopped | TSG stopped | PCG approved |
| --- | --- | --- | --- | --- | --- | --- | --- | --- | --- | --- | --- | --- | --- | --- | --- | --- | --- | --- | --- | --- | --- | --- | --- | --- | --- |
| 6832 | 2170 | **Multimedia Priority Service** | 858d? | 2006-06-08 A | 2009-09-18 A | 100% | 2006-06-08 | 2009-09-18 | 858d? |  | S1; C1; C3; C4 | 43016h | 43016h | PRIOR_EMR | Telcordia | jgarraha@telcordia.com | Rel-8 | 34 | Alain | Public Safety (I-A) | PRIOR |  |  |  |  |
| 6833 | 2170.1 | Service Requirements for PRIOR | 391d? | 2006-06-08 A | 2007-12-06 A | 100% | 2006-06-08 | 2007-12-06 | 391d? | finish no earlier than 2007-11-30 | S1 | 3128h | 3128h | PRIOR_EMR | Telcordia | jgarraha@telcordia.com | Rel-8 | 32 | Alain | Public Safety (I-A) | PRIOR-EMR | New 22.153 |  |  |  |
| 6834 | 2170.2 | CT1 part of Stage 3 for PRIOR | 732d? | 2006-12-01 A | 2009-09-18 A | 100% | 2006-12-01 | 2009-09-18 | 732d? | finish no earlier than 2009-09-18 | C1 | 5856h | 5856h | PRIOR_EMR | Alcatel-Lucent | Keith Drage (drage@alcatel-lucent.com) | Rel-8 | 34 | Frederic | Public Safety (I-A) |  | 24.229 |  |  |  |
| 6835 | 2170.3 | CT4 part of Stage 3 for PRIOR | 381d? | 2007-09-21 A | 2009-03-06 A | 100% | 2007-09-21 | 2009-03-06 | 381d? | finish no earlier than 2009-03-06 | C4 | 3048h | 3048h | PRIOR_EMR | Alcatel-Lucent | Keith Drage (drage@alcatel-lucent.com) | Rel-8 | 37 | Kimmo | Public Safety (I-A) |  | 23.008; 29.228; 29.229 |  |  |  |
| 6836 | 2170.4 | Deleted - Stage 3 for PRIOR | 441d? | 2007-09-21 A | 2009-05-29 A | 100% | 2007-09-21 | 2009-05-29 | 441d? | finish no earlier than 2009-05-29 | C3 | 3528h | 3528h | PRIOR-EMR | Alcatel-Lucent | Keith Drage (drage@alcatel-lucent.com) | Rel-8 | 37 | Adrian | Public Safety (I-A) |  | 29.212; 29.213; 29.214; 29.163 | PCG-23 | CP-44 |  |
| 6837 | 2171 | **Open Service Access (OSA) Rel-8** | 202d? | 2007-08-23 A | 2008-05-30 A | 100% | 2007-08-23 | 2008-05-30 | 202d? |  | S1; C5 | 25528h | 25528h | OSA8 | Orange | Song Dong | Rel-8 |  | Alain |  | OSA8 |  |  |  |  |
| 6838 | 2171.1 | OSA Stage 1 - Service Requirements | 145d? | 2007-08-23 A | 2008-03-12 A | 100% | 2007-08-23 | 2008-03-12 | 145d? | finish no earlier than 2007-12-04 | S1 | 1160h | 1160h | OSA8 | Orange, AePONA | Song Dong | Rel-8 |  | Alain |  |  | 22.127 |  |  |  |
| 6839 | 2171.2 | OSA Stage 1 - NGN Service Requirement | 140d? | 2007-09-03 A | 2008-03-14 A | 100% | 2007-09-03 | 2008-03-14 | 140d? | finish no earlier than 2008-03-14 | S1 | 1120h | 1120h | OSA8-IMSReq | Orange | Song Dong | Rel-8 | 37 | Alain |  | OSA8-IMS | 22.127 |  |  |  |
| 6840 | 2171.3 | **Rel-8 OSA Stage 2/3 enhancements** | 157d? | 2007-10-25 A | 2008-05-30 A | 100% | 2007-10-25 | 2008-05-30 | 157d? |  | C5 | 20016h | 20016h | OSA8-IMS | Alcatel-Lucent | unmehopa@alcatel-lucent.com | Rel-8 |  | Kimmo |  |  | 23.198; 29.198; 29.199 |  |  |  |
| 6841 | 2171.3.1 | Deleted - Ensure Parlay-X composable with identity management frameworks, in particular Liberty Alliance | 157d? | 2007-10-25 A | 2008-05-30 A | 100% | 2007-10-25 | 2008-05-30 | 157d? | finish no earlier than 2008-12-25 | C5 | 1256h | 1256h |  | Ericsson | catherine.mulligan@ericsson.com | Rel-8 | 37 | Kimmo |  |  | existing 29.199-xy | PCG-21 | CP-40 | 21 |
| 6842 | 2171.3.2 | Parlay-X Content Management web service (store/manage meta-data) | 157d? | 2007-10-25 A | 2008-05-30 A | 100% | 2007-10-25 | 2008-05-30 | 157d? | finish no earlier than 2008-12-04 | C5 | 1256h | 1256h | OSA8-IMS | Alcatel-Lucent | unmehopa@alcatel-lucent.com | Rel-8 | 37 | Kimmo |  |  | 29.199-21 |  |  |  |
| 6843 | 2171.3.3 | Parlay-X Policy web service | 157d? | 2007-10-25 A | 2008-05-30 A | 100% | 2007-10-25 | 2008-05-30 | 157d? | finish no earlier than 2008-12-04 | C5 | 1256h | 1256h | OSA8-IMS | Alcatel-Lucent | unmehopa@alcatel-lucent.com | Rel-8 | 37 | Kimmo |  |  | 29.199-22 |  |  |  |
| 6844 | 2171.3.4 | Parlay-X Terminal status web service | 157d? | 2007-10-25 A | 2008-05-30 A | 100% | 2007-10-25 | 2008-05-30 | 157d? | finish no earlier than 2008-05-30 | C5 | 1256h | 1256h | OSA8-IMS | Alcatel-Lucent | unmehopa@alcatel-lucent.com | Rel-8 | 37 | Kimmo |  |  | 29.199-08 |  |  |  |
| 6845 | 2171.3.5 | Deleted - Identify communication format used by a particular application | 157d? | 2007-10-25 A | 2008-05-30 A | 100% | 2007-10-25 | 2008-05-30 | 157d? | finish no earlier than 2008-05-30 | C5 | 1256h | 1256h |  | Ericsson | catherine.mulligan@ericsson.com | Rel-8 | 37 | Kimmo |  |  | existing 29.199-xy | PCG-21 | CP-40 | 21 |
| 6846 | 2171.3.6 | Deleted - Security on User Profile Management - reuse GUP API (22.127 CR 0084 S1-071794) | 128d? | 2007-12-05 A | 2008-05-30 A | 100% | 2007-12-05 | 2008-05-30 | 128d? | finish no earlier than 2008-12-25 | C5 | 1024h | 1024h |  | Telecom Italia | vincenzo.amorino@telecomitalia.it | Rel-8 | 38 | Kimmo |  |  | PXWS Framework | PCG-21 | CP-40 | 21 |
| 6847 | 2171.3.7 | Deleted - Privacy on Subscriber Identity (Liberty Alliance, OASIS) (22.127 CR 0085 S1-071835) | 128d? | 2007-12-05 A | 2008-05-30 A | 100% | 2007-12-05 | 2008-05-30 | 128d? | finish no earlier than 2008-12-25 | C5 | 1024h | 1024h |  | Telecom Italia | vincenzo.amorino@telecomitalia.it | Rel-8 | 38 | Kimmo |  |  | PXWS Framework | PCG-21 | CP-40 | 21 |
| 6848 | 2171.3.8 | Deleted - Topology Hiding (22.127 CR 0086 S1-071838) | 128d? | 2007-12-05 A | 2008-05-30 A | 100% | 2007-12-05 | 2008-05-30 | 128d? | finish no earlier than 2008-12-25 | C5 | 1024h | 1024h |  | Telecom Italia | vincenzo.amorino@telecomitalia.it | Rel-8 | 38 | Kimmo |  |  | PXWS Framework | PCG-21 | CP-40 | 21 |
| 6849 | 2171.3.9 | Deleted - Subscriber event notification (22.127 CR 0087 S1-071836) | 128d? | 2007-12-05 A | 2008-05-30 A | 100% | 2007-12-05 | 2008-05-30 | 128d? | finish no earlier than 2008-12-25 | C5 | 1024h | 1024h |  | Telecom Italia | vincenzo.amorino@telecomitalia.it | Rel-8 | 38 | Kimmo |  |  | PXWS Framework | PCG-21 | CP-40 | 21 |
| 6850 | 2171.3.10 | Deleted - Event notification (22.127 CR 0088 S1-071762) | 128d? | 2007-12-05 A | 2008-05-30 A | 100% | 2007-12-05 | 2008-05-30 | 128d? | finish no earlier than 2008-12-25 | C5 | 1024h | 1024h |  | Telecom Italia | vincenzo.amorino@telecomitalia.it | Rel-8 | 38 | Kimmo |  |  | PXWS Framework | PCG-21 | CP-40 | 21 |
| 6851 | 2171.3.11 | Deleted - Access policy (22.127 CR 0089 S1-071763) | 128d? | 2007-12-05 A | 2008-05-30 A | 100% | 2007-12-05 | 2008-05-30 | 128d? | finish no earlier than 2008-12-25 | C5 | 1024h | 1024h |  | Telecom Italia | vincenzo.amorino@telecomitalia.it | Rel-8 | 38 | Kimmo |  |  | PXWS Framework | PCG-21 | CP-40 | 21 |
| 6852 | 2171.3.12 | Deleted - API usage accounting (22.127 CR 0090 S1-071792) | 128d? | 2007-12-05 A | 2008-05-30 A | 100% | 2007-12-05 | 2008-05-30 | 128d? | finish no earlier than 2008-12-25 | C5 | 1024h | 1024h |  | Telecom Italia | vincenzo.amorino@telecomitalia.it | Rel-8 | 38 | Kimmo |  |  | PXWS Framework | PCG-21 | CP-40 | 21 |
| 6853 | 2171.3.13 | Presence alignment with OMA and IETF (22.127 CR 0092 S1-071764) | 128d? | 2007-12-05 A | 2008-05-30 A | 100% | 2007-12-05 | 2008-05-30 | 128d? | finish no earlier than 2008-05-30 | C5 | 1024h | 1024h | OSA8-IMS | Alcatel-Lucent | unmehopa@alcatel-lucent.com | Rel-8 | 38 | Kimmo |  |  | 29.199-14/13 |  |  | 21 |
| 6854 | 2171.3.14 | Deleted - Service identification (22.127 CR 0095 S1-071837) | 128d? | 2007-12-05 A | 2008-05-30 A | 100% | 2007-12-05 | 2008-05-30 | 128d? | finish no earlier than 2008-05-30 | C5 | 1024h | 1024h |  | Ericsson | catherine.mulligan@ericsson.com | Rel-8 | 38 | Kimmo |  |  | existing 29.199-xy | PCG-21 | CP-40 | 21 |
| 6855 | 2171.3.15 | Framework Enterprise Operator (Service Subscription function) | 102d? | 2008-01-10 A | 2008-05-30 A | 100% | 2008-01-10 | 2008-05-30 | 102d? | finish no earlier than 2008-05-30 | C5 | 816h | 816h | OSA8-IMS | Alcatel-Lucent | unmehopa@alcatel-lucent.com | Rel-8 | 39 | Kimmo |  |  | 29.198-03 |  |  | 21 |
| 6856 | 2171.3.16 | Mobility Emergency Location | 102d? | 2008-01-10 A | 2008-05-30 A | 100% | 2008-01-10 | 2008-05-30 | 102d? | finish no earlier than 2008-05-30 | C5 | 816h | 816h | OSA8-IMS | Alcatel-Lucent | unmehopa@alcatel-lucent.com | Rel-8 | 39 | Kimmo |  |  | 29.198-06 |  |  | 21 |
| 6857 | 2171.3.17 | Connectivity Manager SCF | 102d? | 2008-01-10 A | 2008-05-30 A | 100% | 2008-01-10 | 2008-05-30 | 102d? |  | C5 | 816h | 816h | OSA8-IMS | Alcatel-Lucent | unmehopa@alcatel-lucent.com | Rel-8 | 39 | Kimmo |  |  | 29.198-10 |  |  | 21 |
| 6858 | 2171.3.18 | PAM Presence Agent | 102d? | 2008-01-10 A | 2008-05-30 A | 100% | 2008-01-10 | 2008-05-30 | 102d? | finish no earlier than 2008-05-30 | C5 | 816h | 816h | OSA8-IMS | Alcatel-Lucent | unmehopa@alcatel-lucent.com | Rel-8 | 39 | Kimmo |  |  | 29.198-14 |  |  | 21 |

Notes:
- 6832: CP#45 completed
- 6833: SP#38 completed
- 6834: CP#45 completed
- 6835: CP#43 completed
- 6836: CP#44 stopped (Reason: No Rel-8 solution expected (LS sent to SA2, but not prioritized in SA2)
- 6837: SP#40 maintenance & new OSA work moved to OMA. Rel-9 onwards 3GPP references to 22.127 changed to OMA Parlay Service Access Requirements (OMA-RD-Parlay_Service_Access-V1_0-20100427-A).
- 6838: SP#40 maintenance & new OSA work moved to OMA. Rel-9 onwards 3GPP references to 22.127 changed to OMA Parlay Service Access Requirements (OMA-RD-Parlay_Service_Access-V1_0-20100427-A).
- 6839: SP#40 maintenance & new OSA work moved to OMA
- 6840: SP#40 maintenance & new OSA work moved to OMA
- 6841: CP#40: Work moved to OMA
- 6842: CP#40 completed
- 6843: CP#40 completed
- 6844: CP#40 completed
- 6845: CP#40: Work moved to OMA
- 6846: SP#38 SP-070853 R8 CRs 22.127 OSA Stage 1. CP#40: Work moved to OMA
- 6847: SP#38 SP-070853 R8 CRs 22.127 OSA Stage 1. CP#40: Work moved to OMA
- 6848: SP#38 SP-070853 R8 CRs 22.127 OSA Stage 1. CP#40: Work moved to OMA
- 6849: SP#38 SP-070853 R8 CRs 22.127 OSA Stage 1. CP#40: Work moved to OMA
- 6850: SP#38 SP-070853 R8 CRs 22.127 OSA Stage 1. CP#40: Work moved to OMA
- 6851: SP#38 SP-070853 R8 CRs 22.127 OSA Stage 1. CP#40: Work moved to OMA
- 6852: SP#38 SP-070853 R8 CRs 22.127 OSA Stage 1. CP#40: Work moved to OMA
- 6853: CP#40 completed
- 6854: SP#38 SP-070853 R8 CRs 22.127 OSA Stage 1. CP#40: Work moved to OMA
- 6855: CP#40 completed
- 6856: CP#40 completed
- 6857: CP#40 completed
- 6858: CP#40 completed

| ID | WBS | Task | Duration | Start | Finish | Complete | Remaining | Baseline start | Baseline finish | Baseline duration | Total slack | Constraint | Resources | Work | Actual work | Acronym | WI rapporteur name | Release | MCC resp | Acronym_3GU_Export | TSG approved | PCG approved | Status Report | Special Focus Doc |
| --- | --- | --- | --- | --- | --- | --- | --- | --- | --- | --- | --- | --- | --- | --- | --- | --- | --- | --- | --- | --- | --- | --- | --- | --- |
| 6859 | 2172 | **Paging Permission with Access Control (PPACR)** | 389d? | 2007-06-12 A | 2008-12-05 A | 100% |  | 2007-06-12 | 2008-12-05 | 389d? |  |  | S1; C1 | 9000h | 9000h | PPACR | NTT DoCoMo | Rel-8 | Alain | PPACR |  |  |  |  |
| 6860 | 2172.1 | Stage 1 for PPACR | 69d? | 2007-06-12 A | 2007-09-14 A | 100% |  | 2007-06-12 | 2007-09-14 | 69d? |  | finish no earlier than 2007-09-14 | S1 | 552h | 552h | PPACR-S1 | NTT DoCoMo | Rel-8 | Alain | PPACR-S1 | 37 |  |  |  |
| 6861 | 2172.2 | Stage 3 for PPACR (CT1) | 278d? | 2007-11-14 A | 2008-12-05 A | 100% |  | 2007-11-14 | 2008-12-05 | 278d? |  | finish no earlier than 2008-12-05 | C1 | 2224h | 2224h | PPACR-CT1 | NTT DoCoMo | Rel-8 | Frederic | PPACR-CT1 | 38 | 21 |  |  |
| 6862 | 2173 | Conformance Test Aspects – Paging Permission with Access Control (PPAC) | 61d? | 2010-09-17 A | 2010-12-10 A | 100% |  | 2010-09-17 | 2010-12-10 | 61d? |  | finish no earlier than 2010-12-10 | R5 | 488h | 488h | PPAC_UEConTest | NTT DoCoMo | Rel-8 | Ingbert | PPAC_UEConTest | 49 | 25 | RP-101074 |  |
| 6863 | 2174 | **Charging for multi-phases services** | 70d? | 2007-12-06 A | 2008-03-12 | 99% | 0d? | 2007-12-06 | 2008-03-12 | 70d? | 0d |  | S1 | 560h | 560h | CHRGMPH | Telecom Italia | Rel-8 | Alain | CHRGMPH | 38 | 21 |  |  |
| 6864 | 2174.1 | Stage 1 for CHRGMPH | 70d? | 2007-12-06 A | 2008-03-12 A | 100% |  | 2007-12-06 | 2008-03-12 | 70d? |  | start no earlier than 2007-12-06 | S1 | 560h | 560h | CHRGMPH-s1 | Telecom Italia | Rel-8 | Alain | CHRGMPH-s1 | 38 | 21 |  |  |
| 6865 | 2175 | **Home NodeB / eNodeB** | 327d? | 2007-12-06 A | 2009-03-06 A | 100% |  | 2007-12-06 | 2009-03-06 | 327d? |  |  | S1; C1; C4 | 10952h | 10952h | HomeNB | Vodafone | Rel-8 | Alain | HomeNB | 38 | 21 |  | HNB |
| 6866 | 2175.1 | Stage 1 for Home NodeB / eNodeB | 70d? | 2007-12-06 A | 2008-03-12 A | 100% |  | 2007-12-06 | 2008-03-12 | 70d? |  | start no earlier than 2007-12-06 | S1 | 560h | 560h | HomeNB-S1 | Vodafone | Rel-8 | Alain | HomeNB-S1 | 38 | 21 |  | HNB |
| 6867 | 2175.2 | Support of Closed Subscriber Group (CSG) | 66d? | 2008-12-05 A | 2009-03-06 A | 100% |  | 2008-12-05 | 2009-03-06 | 66d? |  | finish no earlier than 2009-03-06 | C4 | 528h | 528h |  | CT#42 | Rel-8 | Kimmo |  | 42 | 22 |  | HNB |
| 6868 | 2175.3 | CSG and Idle Mode Mobility for LTE Home eNodeB | 126d? | 2008-09-12 A | 2009-03-06 A | 100% |  | 2008-09-12 | 2009-03-06 | 126d? |  | finish no earlier than 2009-03-06 | C1 | 1008h | 1008h | HomeNB-LTE | Huawei | Rel-8 | Frederic | HomeNB-LTE | 41 | 21 |  | HNB |
| 6869 | 2175.4 | CSG and Idle Mode Mobility for 3G Home NodeB | 126d? | 2008-09-12 A | 2009-03-06 A | 100% |  | 2008-09-12 | 2009-03-06 | 126d? |  | finish no earlier than 2009-03-06 | C1 | 1008h | 1008h | HomeNB-3G | Qualcomm | Rel-8 | Frederic | HomeNB-3G | 41 | 21 |  | HNB |
| 6870 | 2176 | **UTRA HNB** | 326d? | 2008-03-07 A | 2009-06-04 A | 100% |  | 2008-03-07 | 2009-06-04 | 326d? |  |  | RP; S5 | 11008h | 11008h | HNB |  | Rel-8 | Issam | HNB | 39 | 21 |  | HNB |
| 6871 | 2176.1 | Support of UTRA HNB | 201d? | 2008-05-30 A | 2009-03-06 A | 100% |  | 2008-05-30 | 2009-03-06 | 201d? |  | finish no earlier than 2009-03-06 | R2 | 1608h | 1608h | HNB-supp | Huawei | Rel-8 | Yong-Jun | HNB-supp | 40 | 21 | RP-090040 | HNB |
| 6872 | 2176.2 | UTRAN Architecture for 3G HNB | 136d? | 2008-05-30 A | 2008-12-05 A | 100% |  | 2008-05-30 | 2008-12-05 | 136d? |  | finish no earlier than 2008-12-05 | R3 | 1088h | 1088h | HNB-arch | Alcatel-Lucent | Rel-8 | Juha | HNB-arch | 40 | 21 | RP-090042 | HNB |
| 6873 | 2176.3 | FDD Home NodeB RF requirements | 261d? | 2008-03-07 A | 2009-03-06 A | 100% |  | 2008-03-07 | 2009-03-06 | 261d? |  | finish no earlier than 2009-03-06 | R4 | 2088h | 2088h | HNB-RF | Motorola | Rel-8 | Issam | HNB-RF | 39 | 21 | RP-090041 | HNB |
| 6874 | 2176.4 | 3G Home NodeB OAM&P Type 1 Management Interface | 127d? | 2008-12-11 A | 2009-06-04 A | 100% |  | 2008-12-11 | 2009-06-04 | 127d? |  | finish no earlier than 2009-06-04 | S5 | 1008h | 1008h | HNB-3G_OAM | Huawei | Rel-8 | Mirko | HNB-3G_OAM | 42 | 22 |  | HNB |
| 6875 | 2177 | **UTRA HNB – UE Conformance Testing** | 327d? | 2009-03-06 A | 2010-06-04 A | 100% |  | 2009-03-06 | 2010-06-04 | 327d? |  |  | R5 | 5224h | 5224h | HNB-UEConTest |  | Rel-8 | Ingbert | HNB-UEConTest | 43 | 22 |  | HNB |
| 6876 | 2177.1 | Conformance Test Aspects – UTRA HNB (FDD) | 326d? | 2009-03-06 A | 2010-06-04 A | 100% |  | 2009-03-06 | 2010-06-04 | 326d? |  | finish no earlier than 2010-06-04 | R5 | 2608h | 2608h | HNB-UEConTestFDD | Huawei | Rel-8 | Ingbert | HNB-UEConTestFDD | 43 | 22 | RP-100482 | HNB |
| 6877 | 2178 | Lawful Interception in the 3GPP Rel-8 | 524d? | 2007-03-12 A | 2009-03-12 A | 100% |  | 2007-03-12 | 2009-03-12 | 524d? |  | finish no earlier than 2009-03-12 | S3 | 4192h | 4192h | LI8 | BMWI, Verizon | Rel-8 | Mirko | LI8 |  |  |  |  |
| 6878 | 2179 | **Generic Bootstrapping Architecture Push Function** | 258d? | 2008-03-12 A | 2009-03-06 A | 100% |  | 2008-03-12 | 2009-03-06 | 258d? |  |  | S3; C1; C4 | 10596.8h | 10596.8h | GBAPush | Ericsson | Rel-8 | Mirko | GBAPush | 39 | 21 |  |  |
| 6879 | 2179.1 | SA3 part of GBAPush (33.223) | 193d? | 2008-03-12 A | 2008-12-05 A | 100% |  | 2008-03-12 | 2008-12-05 | 193d? |  | finish no earlier than 2008-12-05 | S3 | 1544h | 1544h | GBAPush | Ericsson | Rel-8 | Mirko |  | 39 | 21 |  |  |
| 6880 | 2179.2 | CT1 part of GBAPush | 178.8d? | 2008-03-12 A | 2009-03-06 A | 100% |  | 2008-03-12 | 2009-03-06 | 178.8d? |  | finish no earlier than 2009-03-06 | C1 | 1430.4h | 1430.4h | GBAPush | Ericsson | Rel-8 | Frederic |  | 39 | 21 |  |  |
| 6881 | 2179.3 | CT4 part of GBAPush | 178.8d? | 2008-03-12 A | 2009-03-06 A | 100% |  | 2008-03-12 | 2009-03-06 | 178.8d? |  | finish no earlier than 2009-03-06 | C4 | 1430.4h | 1430.4h | GBAPush | Ericsson | Rel-8 | Kimmo |  | 39 | 21 |  |  |
| 6882 | 2180 | Requirements and Test methods for Wideband Terminals | 197d? | 2008-03-12 A | 2008-12-11 A | 100% |  | 2008-03-12 | 2008-12-11 | 197d? |  | start no earlier than 2008-03-12 | S4 | 1576h | 1576h | RETEM_WB_T | FT, Ericsson | Rel-8 | Paolo | RETEM_WB_T |  |  |  |  |
| 6883 | 2181 | Extending PSS and MBMS User Services for optimized Mobile TV | 266d? | 2007-12-06 A | 2008-12-11 A | 100% |  | 2007-12-06 | 2008-12-11 | 266d? |  | finish no earlier than 2008-12-11 | S4 | 2128h | 2128h | PSS_MBMS_OMTV | Ericsson | Rel-8 | Paolo | PSS_MBMS_OMTV |  |  |  |  |

Notes:
- 6859: CP#42 completed. Triggered by Study UID_330016 (PPAC). / WI rapporteur e-mail: Morita Takashi
- 6860: SP#37 completed / Impacted TSs and TRs: 22.011 / WI rapporteur e-mail: Morita Takashi
- 6861: CP#42 completed / Impacted TSs and TRs: 24.008; 23.122; 24.301
- 6862: RP#50 completed / Impacted TSs and TRs: UTRA 34.108; 34.123-1; 34.123-2; 34.123-3 / WI rapporteur e-mail: Takao.Shimizu.rp@nttdocomo.com
- 6863: SP#39 Stage 1 completed / Impacted TSs and TRs: 22.115 / WI rapporteur e-mail: Marco.DeLuca1@telecomitalia.it
- 6864: SP#39 completed / Impacted TSs and TRs: 22.115 / WI rapporteur e-mail: Marco.DeLuca1@telecomitalia.it
- 6865: CP#43 completed / WI rapporteur e-mail: John Watson
- 6866: SP#39 completed / Impacted TSs and TRs: 22.011; 22.115 / WI rapporteur e-mail: John Watson
- 6867: CP#43 completed. SP#42 SP-080874 22.011CR0141 confirmed Requirement to support roaming subscribers with CSG home network subscription but did NOT confirmed requirement for home network independent support of roamers in CSG / Impacted TSs and TRs: 29.002; 29.272; 23.008; 23.003 / WI rapporteur e-mail: Hannu Hietalahti
- 6868: CP#43 completed / Impacted TSs and TRs: 23.122; new (24.285; 24.301; 24.801) / WI rapporteur e-mail: zhang.peng@huawei.com
- 6869: CP#43 completed / Impacted TSs and TRs: 23.122; 24.008; new 24.285 / WI rapporteur e-mail: Osok Song
- 6870: SP#44 completed
- 6871: RP#43 completed / Impacted TSs and TRs: 25.304; 25.306; 25.331; new 25.367 / WI rapporteur e-mail: Yang Xudong (yangxudong@huawei.com)
- 6872: RP#42 completed / Impacted TSs and TRs: 25.401; 25.410; 25.412; 25.413; 25.414; 25.415; new (25.467; 25.468; 25.469) / WI rapporteur e-mail: Martin Warner (mw15@alcatel-lucent.com)
- 6873: RP#43 completed / Impacted TSs and TRs: 25.104; 25.141; new 25.967 / WI rapporteur e-mail: Ying Cai (yingcai@motorola.com)
- 6874: SP#44 completed. Complements work in BroadBand Forum / Impacted TSs and TRs: new (32.581; 32.582; 32.583; 32.584) / WI rapporteur e-mail: Zou Lan (zlan@huawei.com)
- 6875: RP#48 FDD completed. Testing for Feature UID_390033 UTRA HNB
- 6876: RP#48 completed / Impacted TSs and TRs: 34.108; 34.123-1; 34.123-2; 34.123-3 / WI rapporteur e-mail: Trica Li (trica_li@huawei.com)
- 6877: SP#43 completed / Impacted TSs and TRs: 33.106; 33.107; 33.108 / WI rapporteur e-mail: berthold.wilhelm@bnetza.de, ron_ryan@verizon.net
- 6878: CP#43 completed / WI rapporteur e-mail: Rolf Blom
- 6879: SP#42 completed 33.223 as Rel-8. TS 33.224 moved to Rel-9 under new UID_420039 / Impacted TSs and TRs: 33.223 / WI rapporteur e-mail: Rolf Blom
- 6880: CP#43 completed / Impacted TSs and TRs: 24.109 / WI rapporteur e-mail: Rolf Blom
- 6881: CP#43 completed / Impacted TSs and TRs: 29.109 / WI rapporteur e-mail: Rolf Blom
- 6882: SP#42 completed. SP#39 WID approved. / Impacted TSs and TRs: 26.131; 26.132 / WI rapporteur e-mail: stephane.ragot@orange-ftgroup.com, wanqing.shi@sonyericsson.com
- 6883: SP#42 completed. SP#38 WID approved. / Impacted TSs and TRs: 26.234; 26.346; 26.946 / WI rapporteur e-mail: thorsten.lohmar@ericsson.com

| ID | WBS | Task | Duration | Start | Finish | Complete | Baseline start | Baseline finish | Baseline duration | Constraint | Resources | Work | Actual work | Acronym | PCG approved | WI rapporteur name | Release | TSG approved | MCC resp | Acronym_3GU_Export | TSG stopped | PCG stopped |
| --- | --- | --- | --- | --- | --- | --- | --- | --- | --- | --- | --- | --- | --- | --- | --- | --- | --- | --- | --- | --- | --- | --- |
| 6884 | 2182 | **Encoding formats, transport formats and media description signalling for interworking, QoE, and other enhancements to MTSI-MHI** | 331d? | 2007-12-06 A | 2009-03-12 A | 100% | 2007-12-06 | 2009-03-12 | 331d? |  | S4; C3; C4 | 14936h | 14936h | MTSI_eMHI | 21 | Ericsson, Qualcomm | Rel-8 | 40 | Paolo | MTSI_eMHI |  |  |
| 6885 | 2182.1 | MTSI Video - Dynamic Rate Adaptation/Signalling of Image Size | 331d? | 2007-12-06 A | 2009-03-12 A | 100% | 2007-12-06 | 2009-03-12 | 331d? | finish no earlier than 2009-03-12 | S4 | 2648h | 2648h | MTSI_eMHI-DRASIS |  | Qualcomm, Samsung | Rel-8 |  | Paolo | MTSI_eMHI-DRASIS |  |  |
| 6886 | 2182.2 | CT3 part of Enhancement of interworking between MTSI and CS networks | 201d? | 2008-05-30 A | 2009-03-06 A | 100% | 2008-05-30 | 2009-03-06 | 201d? | finish no earlier than 2009-03-06 | C3 | 1608h | 1608h | MTSI_eMHI | 21 | Huawei | Rel-8 | 40 | Adrian |  |  |  |
| 6887 | 2182.3 | CT4 part of Enhancement of interworking between MTSI and CS networks | 201d? | 2008-05-30 A | 2009-03-06 A | 100% | 2008-05-30 | 2009-03-06 | 201d? | finish no earlier than 2009-03-06 | C4 | 1608h | 1608h | MTSI_eMHI | 21 | Huawei | Rel-8 | 40 | Kimmo |  |  |  |
| 6888 | 2182.4 | Deleted - CT1 part of Enhancement of interworking between MTSI and CS networks | 141d? | 2008-05-30 A | 2008-12-12 A | 100% | 2008-05-30 | 2008-12-12 | 141d? | start no earlier than 2008-05-30 | C1 | 1128h | 1128h | MTSI_eMHI | 21 | Huawei | Rel-8 | 40 | Frederic |  | CP-42 |  |
| 6889 | 2183 | **Rel-8 Operations, Administration, Maintenance and Provisioning (OAM&P)** | 1445d? | 2007-06-07 A | 2012-12-07 A | 100% | 2007-06-07 | 2012-12-07 | 1445d? |  | S5; C1; C4; IETF | 125494h | 125494h | OAM8 |  |  | Rel-8 | 34 | Mirko | OAM8 |  |  |
| 6890 | 2183.1 | **Rel-8 Network Infrastructure Management** | 653d? | 2007-06-07 A | 2009-12-04 A | 100% | 2007-06-07 | 2009-12-04 | 653d? |  | S5 | 19464h | 19464h | OAM8-NIM |  |  | Rel-8 | 34 | Mirko | OAM8-NIM |  |  |
| 6891 | 2183.1.1 | Telecom Management Methodology | 461d? | 2007-06-07 A | 2009-03-12 A | 100% | 2007-06-07 | 2009-03-12 | 461d? | finish no earlier than 2009-03-12 | S5 | 3688h | 3688h | OAM8-NIM |  | Ericsson | Rel-8 |  | Mirko |  |  |  |
| 6892 | 2183.1.2 | Advanced Alarming on Itf-N | 266d? | 2007-06-07 A | 2008-06-12 A | 100% | 2007-06-07 | 2008-06-12 | 266d? | finish no earlier than 2008-12-11 | S5 | 2128h | 2128h | OAM8-NIM |  | Nokia Siemens Networks | Rel-8 |  | Mirko |  |  |  |
| 6893 | 2183.1.3 | CN CS Bearer Transport Network (BTN) relative NRM | 266d? | 2007-06-07 A | 2008-06-12 A | 100% | 2007-06-07 | 2008-06-12 | 266d? | finish no earlier than 2008-12-11 | S5 | 2128h | 2128h | OAM8-NIM |  | China Mobile | Rel-8 |  | Mirko |  |  |  |
| 6894 | 2183.1.4 | Alignment with eTOM and M.3060 architectural concepts | 210d? | 2008-02-22 A | 2008-12-11 A | 100% | 2008-02-22 | 2008-12-11 | 210d? | start no earlier than 2008-02-22 | S5 | 1680h | 1680h | OAM8-NIM | 21 | TeliaSonera | Rel-8 | 39 | Mirko |  |  |  |
| 6895 | 2183.1.5 | IRP SOAP Solution Sets | 201d? | 2008-06-05 A | 2009-03-12 A | 100% | 2008-06-05 | 2009-03-12 | 201d? | finish no earlier than 2009-03-12 | S5 | 1608h | 1608h | OAM8-NIM | 21 | Ericsson | Rel-8 | 40 | Mirko |  |  |  |
| 6896 | 2183.1.6 | Create missing specifications for IRP XML definitions | 52d? | 2009-09-24 A | 2009-12-04 A | 100% | 2009-09-24 | 2009-12-04 | 52d? | finish no earlier than 2010-03-12 | S5 | 416h | 416h | OAM8-NIM | 23 | ZTE | Rel-8 | 45 | Mirko |  |  |  |
| 6897 | 2183.1.7 | Deleted - End point modelling for reference point | 324d? | 2007-09-17 A | 2008-12-11 A | 100% | 2007-09-17 | 2008-12-11 | 324d? | finish no earlier than 2008-12-11 | S5 | 2592h | 2592h | OAM8-NIM |  | Motorola | Rel-8 | 37 | Mirko |  | SP-41 | PCG-21 |
| 6898 | 2183.2 | **Rel-8 Performance Management** | 461d? | 2007-06-07 A | 2009-03-12 A | 100% | 2007-06-07 | 2009-03-12 | 461d? |  | S5 | 13712h | 13712h | OAM8-PM |  |  | Rel-8 | 34 | Mirko | OAM8-PM |  |  |
| 6899 | 2183.2.1 | IP bearer network Performance measurement definitions | 396d? | 2007-06-07 A | 2008-12-11 A | 100% | 2007-06-07 | 2008-12-11 | 396d? | finish no earlier than 2008-12-11 | S5 | 3168h | 3168h | OAM8-PM |  | China Mobile | Rel-8 |  | Mirko |  |  |  |
| 6900 | 2183.2.2 | HSUPA performance measurements | 396d? | 2007-06-07 A | 2008-12-11 A | 100% | 2007-06-07 | 2008-12-11 | 396d? | finish no earlier than 2008-12-11 | S5 | 3168h | 3168h | OAM8-PM |  | China Mobile | Rel-8 |  | Mirko |  |  |  |
| 6901 | 2183.2.3 | Key Performance Indicators (KPIs) for UMTS and GSM | 461d? | 2007-06-07 A | 2009-03-12 A | 100% | 2007-06-07 | 2009-03-12 | 461d? | finish no earlier than 2009-03-12 | S5 | 3688h | 3688h | OAM8-PM |  | China Mobile | Rel-8 |  | Mirko |  |  |  |
| 6902 | 2183.3 | **Rel-8 Trace Management** | 1249d? | 2008-03-07 A | 2012-12-07 A | 100% | 2008-03-07 | 2012-12-07 | 1249d? |  | C1; C4; IETF | 40854.4h | 40854.4h | OAM8-Trace |  |  | Rel-8 | 34 | Mirko | OAM8-Trace |  |  |
| 6903 | 2183.3.1 | CT1 part of Service Level Tracing in IMS | 196d? | 2008-03-07 A | 2008-12-05 A | 100% | 2008-03-07 | 2008-12-05 | 196d? | finish no earlier than 2008-12-05 | C1 | 1568h | 1568h | OAM8-Trace |  | Vodafone | Rel-8 |  | Frederic |  |  |  |
| 6904 | 2183.3.2 | (IETF) Service Level Tracing in IMS (draft-ietf-insipid-logme-marking) --> RFC 8497 | 717d? | 2008-03-07 A | 2012-12-07 A | 100% | 2008-03-07 | 2012-12-07 | 717d? | finish no earlier than 2012-12-07 | C1-IETF | 5736h | 5736h | OAM8-Trace | 27 | Peter Dawes | Rel-8 | 52 | Frederic |  |  |  |
| 6905 | 2183.3.3 | Deleted - (IETF) Service Level Tracing in IMS (draft-dawes-sipping-debug-event) | 98d? | 2008-03-07 A | 2011-12-09 A | 100% | 2008-03-07 | 2011-12-09 | 98d? | finish no earlier than 2011-12-09 | C1-IETF | 768.04h | 768.04h | OAM8-Trace | 27 | Peter Dawes | Rel-8 | 53 | Frederic |  |  |  |
| 6906 | 2183.3.4 | CT4 part of Service Level Tracing in IMS | 175.4d? | 2008-03-07 A | 2008-12-05 A | 100% | 2008-03-07 | 2008-12-05 | 175.4d? | finish no earlier than 2008-12-05 | C4 | 1403.2h | 1403.2h | OAM8-Trace | 21 | Vodafone | Rel-8 | 40 | Frederic |  |  |  |
| 6907 | 2183.3.5 | Deleted - CT3 part of Service Level Tracing in IMS | 175.4d? | 2008-03-07 A | 2008-12-05 A | 100% | 2008-03-07 | 2008-12-05 | 175.4d? | finish no earlier than 2008-12-05 | C3 | 1403.2h | 1403.2h | OAM8-Trace | 21 | Vodafone | Rel-8 | 40 | Adrian |  | CP-42 | PCG-22 |
| 6908 | 2183.4 | (IETF) A Two-Way Active Measurement Protocol (TWAMP) (draft-ietf-ippm-twamp) --> RFC 5357 | 653d? | 2008-03-07 A | 2010-09-06 A | 100% | 2007-06-07 | 2009-12-04 | 653d? | finish no earlier than 2008-12-05 | S5-IETF | 5224h | 5224h | OAM8 |  |  | Rel-8 | 34 | Mirko | OAM8-NIM |  |  |

Notes:
- 6884: TSG#43 completed / WI rapporteur e-mail: olle.franceschi@ericsson.com, nleung@qualcomm.com
- 6885: SP#43 completed / Impacted TSs and TRs: 26.114 / WI rapporteur e-mail: nleung@qualcomm.com & kyunghun.jung@samsung.com
- 6886: CP#43 completed / Impacted TSs and TRs: 29.163 / WI rapporteur e-mail: Tingfang Tang (tagna_online@huawei.com)
- 6887: CP#43 completed / Impacted TSs and TRs: 29.332 / WI rapporteur e-mail: Tingfang Tang (tagna_online@huawei.com)
- 6888: CP#42 stopped (No CT1-impact). WID updated CP-080422=>CP-080774 / WI rapporteur e-mail: Tingfang Tang (tagna_online@huawei.com)
- 6889: OAM8 is an umbrella Feature also for OAM&P related TEI8 type of changes that are not part of any other dedicated feature/WI / Impacted TSs and TRs: 30.818
- 6890: -
- 6891: SP#43 completed / Impacted TSs and TRs: 32.155; 32.153 / WI rapporteur e-mail: thomas.tovinger@ericsson.com
- 6892: SP#40 completed / Impacted TSs and TRs: 32.121; 32.122; 32.123 / WI rapporteur e-mail: SUERBAUM, Clemens
- 6893: SP#40 completed / Impacted TSs and TRs: 32.632; 32.633; 32.635 / WI rapporteur e-mail: Li Jian (lijian@chinamobile.com)
- 6894: SP#42 completed / Impacted TSs and TRs: 32.101/2; 32-series / WI rapporteur e-mail: tommy.berggren@teliasonera.com
- 6895: SP#43 completed / Impacted TSs and TRs: 32.111-7; 32.617; 32.417; 32.367; 32.347; 32.111-1; 32.111-2; 32.111-3; 32.111-5; 32.307; 32.317; 32.341; 32.342; 32.343; 32.345; 32.361; 32.362; 32.363; 32.365; 32.411; 32.412; 32.413; 32.415; 32.611; 32.612; 32.613; 32.615; 32.625 / WI rapporteur e-mail: edwin.tse@ericsson.com
- 6896: SP#46 completed. Create missing XML definitions specs for IRPs (Advanced Alarm Management, Communication Surveillance, Self-Configuration of Network Elements, Software Management) needed for implementation of Rel-8 Notification Log IRP (TS 32.33x) / Impacted TSs and TRs: new (32.125; 32.355; 32.505; 32.535); 32.150; 32.153; 32.335 / WI rapporteur e-mail: Shuqiang Huang (huangsq@zte.com.cn)
- 6897: SP#41 Work stopped. Contributions related to E-UTRAN/EPC to be submitted to UID_380036 E-UTRAN NRM IRP/ UID_380037 EPC NRM IRP / Impacted TSs and TRs: 32.152; 32.62/3/4x; 32.73x / WI rapporteur e-mail: Yizhi Yao (yzyao@motorola.com)
- 6898: - / WI rapporteur e-mail: Li Jian (lijian@chinamobile.com)
- 6899: SP#42 completed / Impacted TSs and TRs: 32.321; 32.322; 32.323; 32.325 / WI rapporteur e-mail: lilianyuan@chinamobile.com
- 6900: SP#42 completed / Impacted TSs and TRs: 32.405 / WI rapporteur e-mail: Li Jian (lijian@chinamobile.com)
- 6901: SP#43 completed / Impacted TSs and TRs: 32.410 / WI rapporteur e-mail: Li Jian (lijian@chinamobile.com), Liang Shuangchun (liangshuangchun@cmdi.chinamobile.com)
- 6902: -
- 6903: CP#42 completed / Impacted TSs and TRs: 24.323; 24.229 / WI rapporteur e-mail: peter.dawes@vodafone.com
- 6904: CP#58 Removed from Rel-8, Rel-9 and Rel-10 (Not completed internet-draft); 26/6/19: 100%->100 / Impacted TSs and TRs: Rel-11 remains draft-dawes-dispatch-debug / WI rapporteur e-mail: peter.dawes@vodafone.com
- 6905: CP#54 Draft removed from 3GPP documentation, covered by draft-dawes-sipping-debug; 9/4/21: 100%->100 / Impacted TSs and TRs: draft-dawes-sipping-debug-event / WI rapporteur e-mail: peter.dawes@vodafone.com
- 6906: CP#42 completed / Impacted TSs and TRs: 29.228; 29.229 / WI rapporteur e-mail: peter.dawes@vodafone.com
- 6907: CP#42 stopped (No CT3-impact) / WI rapporteur e-mail: peter.dawes@vodafone.com
- 6908: -

| ID | WBS | Task | Type | Duration | Start | Finish | Complete | Baseline start | Baseline finish | Baseline duration | Constraint | Resources | Work | Actual work | Acronym | Release | MCC resp | Acronym_3GU_Export | WI rapporteur name | WI rapporteur e-mail | PCG approved | TSG approved | PCG stopped | TSG stopped | Status Report |
| --- | --- | --- | --- | --- | --- | --- | --- | --- | --- | --- | --- | --- | --- | --- | --- | --- | --- | --- | --- | --- | --- | --- | --- | --- | --- |
| 6909 | 2184 | **Rel-8 Charging Management small Enhancements** |  | 716d? | 2006-03-16 A | 2008-12-11 A | 100% | 2006-03-16 | 2008-12-11 | 716d? |  | S5 | 12544h | 12544h | CH8 | Rel-8 | Mirko | CH8 |  |  |  |  |  |  |  |
| 6910 | 2184.1 | Online charging correlation |  | 457d? | 2006-03-16 A | 2007-12-14 A | 100% | 2006-03-16 | 2007-12-14 | 457d? | start no earlier than 2006-03-16 | S5 | 3656h | 3656h | CH8 | Rel-8 | Mirko |  | Orange | Chahine, Rony |  |  |  |  |  |
| 6911 | 2184.2 | SMS online charging |  | 137d? | 2007-06-07 A | 2007-12-14 A | 100% | 2007-06-07 | 2007-12-14 | 137d? | finish no earlier than 2007-12-14 | S5 | 1096h | 1096h | CH8 | Rel-8 | Mirko |  | Vodafone | Gavin.Wong@vodafone.com |  |  |  |  |  |
| 6912 | 2184.3 | Introduce Online Charging from SMS-SC into the SMS Charging Specifications |  | 61d? | 2008-09-18 A | 2008-12-11 A | 100% | 2008-09-18 | 2008-12-11 | 61d? | finish no earlier than 2008-12-11 | S5 | 488h | 488h | CH8 | Rel-8 | Mirko |  | Acision | erik.gebler@acision.com | 21 | 41 |  |  |  |
| 6913 | 2184.4 | Deleted - WLAN Offline Charging |  | 244d? | 2008-01-07 A | 2008-12-11 A | 100% | 2008-01-07 | 2008-12-11 | 244d? | finish no earlier than 2008-12-11 | S5 | 1952h | 1952h | CH8 | Rel-8 | Mirko |  | Alcatel-Lucent | maryse.gardella@alcatel-lucent.com | 21 | 38 | PCG-22 | SP-42 |  |
| 6914 | 2185 | **Conferencing enhancements for Mp interface** |  | 266d? | 2007-11-30 A | 2008-12-05 A | 100% | 2007-11-30 | 2008-12-05 | 266d? |  | C4 | 6384h | 6384h | eMp | Rel-8 | Kimmo | eMp | Huawei | Chencheng@huawei.com | 21 |  |  |  |  |
| 6915 | 2185.1 | Stage 2 for eMp |  | 266d? | 2007-11-30 A | 2008-12-05 A | 100% | 2007-11-30 | 2008-12-05 | 266d? | finish no earlier than 2008-12-11 | C4 | 2128h | 2128h | eMp | Rel-8 | Kimmo |  | Huawei | Chencheng@huawei.com | 21 | 38 |  |  |  |
| 6916 | 2185.2 | Stage 3 for eMp |  | 266d? | 2007-11-30 A | 2008-12-05 A | 100% | 2007-11-30 | 2008-12-05 | 266d? | finish no earlier than 2008-12-05 | C4 | 2128h | 2128h | eMp | Rel-8 | Kimmo |  | Huawei | Chencheng@huawei.com | 21 | 38 |  |  |  |
| 6917 | 2186 | **Contact Manager for 3GPP UICC applications** |  | 642d? | 2006-06-22 A | 2008-12-05 A | 100% | 2006-06-22 | 2008-12-05 | 642d? |  | C6 | 13352h | 13352h | eUPHBOOK | Rel-8 | Xavier | eUPHBOOK | Gemalto | Jacques.seif@gemalto.com |  |  |  |  |  |
| 6918 | 2186.1 | Requirements for Contact Manager |  | 392d? | 2006-06-22 A | 2007-12-21 A | 100% | 2006-06-22 | 2007-12-21 | 392d? | finish no earlier than 2007-12-21 | C6 | 3136h | 3136h | eUPHBOOK-St1 | Rel-8 | Xavier | eUPHBOOK-St1 | Gemalto | Jacques.seif@gemalto.com |  |  |  |  |  |
| 6919 | 2186.2 | External interface for eUPHBOOK |  | 220d? | 2007-05-07 A | 2008-03-07 A | 100% | 2007-05-07 | 2008-03-07 | 220d? | finish no earlier than 2008-03-07 | C6 | 1760h | 1760h | eUPHBOOK-Ext_Spec | Rel-8 | Xavier | eUPHBOOK-Ext_Spec | Gemalto | Jacques.seif@gemalto.com |  |  |  |  |  |
| 6920 | 2186.3 | Internal interface for eUPHBOOK |  | 415d? | 2007-05-07 A | 2008-12-05 A | 100% | 2007-05-07 | 2008-12-05 | 415d? | finish no earlier than 2008-12-05 | C6 | 3320h | 3320h | eUPHBOOK-Int_Spec | Rel-8 | Xavier | eUPHBOOK-Int_Spec | Gemalto | Jacques.seif@gemalto.com |  | 37 |  |  |  |
| 6921 | 2186.4 | Deleted - Implementation of eUPHBOOK | milestone | 0d? | 2007-06-21 A | 2007-06-21 A | 100% | 2007-06-21 | 2007-06-21 | 0d? | start no earlier than 2007-06-21 | C6 |  |  | eUPHBOOK-St23 | Rel-8 | Xavier | eUPHBOOK-St23 | Giesecke & Devrient | Claus Dietze |  |  |  | SP-33 |  |
| 6922 | 2187 | **Rel-8 LTE – 3G Long Term Evolution - Evolved Packet System RAN part** |  | 644d? | 2006-09-25 A | 2009-03-12 A | 100% | 2006-09-25 | 2009-03-12 | 644d? |  | RP; S5 | 50048h | 50048h | LTE | Rel-8 |  | LTE | NTT DoCoMo | Takehiro Nakamura (nakamurata@nttdocomo.co.jp) |  |  |  |  | RP-080741 |
| 6923 | 2187.1 | LTE – Physical Layer |  | 380d? | 2006-09-25 A | 2008-03-07 A | 100% | 2006-09-25 | 2008-03-07 | 380d? | finish no earlier than 2007-09-14 | R1 | 3040h | 3040h | LTE-Phys | Rel-8 | Patrick | LTE-Phys | NTT DoCoMo | Sadayuki Abeta |  |  |  |  | RP-080741 |
| 6924 | 2187.2 | LTE – Radio Interface Layer 2 and 3 Protocol Aspect |  | 575d? | 2006-09-25 A | 2008-12-05 A | 100% | 2006-09-25 | 2008-12-05 | 575d? | finish no earlier than 2008-12-11 | R2 | 4600h | 4600h | LTE-L23 | Rel-8 | Yong-Jun | LTE-L23 | Nokia Siemens Networks | benoist.sebire@nokia.com |  |  |  |  | RP-080741 |
| 6925 | 2187.3 | LTE – eUTRAN Interfaces |  | 575d? | 2006-09-25 A | 2008-12-05 A | 100% | 2006-09-25 | 2008-12-05 | 575d? | finish no earlier than 2008-12-11 | R3 | 4600h | 4600h | LTE-interfaces | Rel-8 | Juha | LTE-interfaces | Ericsson | Martin Israelsson |  |  |  |  | RP-080741 |
| 6926 | 2187.4 | LTE – Evolved UTRA and UTRAN RF Radio Transmission/Reception, System Performance Requirements and Conformance Testing |  | 575d? | 2006-09-25 A | 2008-12-05 A | 100% | 2006-09-25 | 2008-12-05 | 575d? | finish no earlier than 2008-12-11 | R4 | 4600h | 4600h | LTE-RF | Rel-8 | Issam | LTE-RF | Nokia Siemens Networks | Tuomo Saynajakangas |  |  |  |  | RP-080741 |
| 6927 | 2187.5 | LTE – FDD repeaters |  | 386d? | 2007-09-14 A | 2009-03-06 A | 100% | 2007-09-14 | 2009-03-06 | 386d? | finish no earlier than 2009-03-06 | R4 | 3088h | 3088h | LTE-Repeaters | Rel-8 | Issam | LTE-Repeaters | Powerwave Technologies, Andrew Wireless | ralf.michanikl@andrew.com, Alf.Ahlstrom@pwav.com |  | 37 |  |  | RP-090037 |
| 6928 | 2187.6 | **E-UTRAN Data Definitions** |  | 389d? | 2007-09-17 A | 2009-03-12 A | 100% | 2007-09-17 | 2009-03-12 | 389d? |  | S5 | 13096h | 13096h | E-UTRAN-OAM | Rel-8 | Mirko | E-UTRAN-OAM |  |  | 21 | 39 |  |  |  |
| 6929 | 2187.6.1 | Subscriber and Equipment Trace for E-UTRAN and EPC |  | 389d? | 2007-09-17 A | 2009-03-12 A | 100% | 2007-09-17 | 2009-03-12 | 389d? | finish no earlier than 2009-03-12 | S5 | 3112h | 3112h | E-UTRAN-OAM | Rel-8 | Mirko |  | Ericsson | robert.petersen@ericsson.com |  | 37 |  |  |  |
| 6930 | 2187.6.2 | E-UTRAN Network Resource Model (NRM) Integration Reference Point (IRP) |  | 309d? | 2008-01-07 A | 2009-03-12 A | 100% | 2008-01-07 | 2009-03-12 | 309d? | finish no earlier than 2009-03-12 | S5 | 2472h | 2472h | E-UTRAN-OAM | Rel-8 | Mirko |  | Ericsson | ELMDAHL, Per | 21 | 38 |  |  |  |
| 6931 | 2187.6.3 | Performance measurements for E-UTRAN |  | 275d? | 2008-02-22 A | 2009-03-12 A | 100% | 2008-02-22 | 2009-03-12 | 275d? | finish no earlier than 2009-03-12 | S5 | 2200h | 2200h | E-UTRAN-OAM | Rel-8 | Mirko |  | Motorola, Huawei | Yizhi Yao (yzyao@motorola.com) | 21 | 39 |  |  |  |
| 6932 | 2187.6.4 | Key Performance Indicators (KPIs) for E-UTRAN |  | 275d? | 2008-02-22 A | 2009-03-12 A | 100% | 2008-02-22 | 2009-03-12 | 275d? | finish no earlier than 2009-03-12 | S5 | 2200h | 2200h | E-UTRAN-OAM | Rel-8 | Mirko |  | Ericsson | ulf.hubinette@ericsson.com | 21 | 39 |  |  |  |

Notes:
- 6909: CH8 is an umbrella Feature also for OAM&P related TEI8 type of changes that are not part of any other dedicated feature/WI / Impacted TSs and TRs: 30.818
- 6910: SP#38 completed / Impacted TSs and TRs: 32.296
- 6911: SP#38 completed / Impacted TSs and TRs: 32.240; 32.299; new 32.274
- 6912: SP#42 completed. Linked to SA2 UID 32081 (Support of SMS over IP networks) and CT4 UID 340016 (Routeing of MT-SMS via the HPLMN). / Impacted TSs and TRs: 32.274; 32.299
- 6913: SP#42 stopped / Impacted TSs and TRs: 32.252; 32.298; 32.299
- 6914: CP#42 completed
- 6915: CP#42 completed / Impacted TSs and TRs: 23.333
- 6916: CP#42 completed / Impacted TSs and TRs: 29.333
- 6917: CP#42 completed. CP#40: WID updated CP-070622=>CP-080382. aka Enhanced USIM phonebook
- 6918: CP#38 completed / Impacted TSs and TRs: 21.111
- 6919: CP#39 completed / Impacted TSs and TRs: new 31.220
- 6920: CP#42 completed / Impacted TSs and TRs: new 31.221
- 6921: SP#33 stopped / Impacted TSs and TRs: 31.102
- 6922: RP#43 completed. Role model for SAE/LTE system wide project management by SA2 in SP-060166 / Impacted TSs and TRs: LTE 36.300; 36.938
- 6923: RP#39 completed / Impacted TSs and TRs: 36.201; 36.211; 36.212; 36.213; 36.214; 25.215; 25.225
- 6924: RP#42 completed / Impacted TSs and TRs: 36.302; 36.304; 36.306; 36.314; 36.321; 36.322; 36.323; 36.331; 25.302; 25.304; 25.331
- 6925: RP#42 completed / Impacted TSs and TRs: 36.401; 36.410; 36.411; 36.412; 36.413; 36.414; 36.420; 36.421; 36.422; 36.423; 36.424; 25.413
- 6926: RP#42 completed. RP#47 abandoned draft 36.801, 36.803, 36.804 / Impacted TSs and TRs: 36.101; 36.104; 36.113; 36.124; 36.133; 36.141; 36.942; 25.123; 25.133
- 6927: RP#43 completed. RP#47 create Rel-9 TR 36.956 (see R4-100386, RP-100320_RAN4 Report) / Impacted TSs and TRs: 36.106; 36.143; 25.113
- 6928: SP#43 completed
- 6929: SP#43 completed / Impacted TSs and TRs: 32.421; 2.422; 32.423; 2.441; 32.442; 32.443; 32.445
- 6930: SP#43 completed / Impacted TSs and TRs: new (32.761; 32.762; 32.763; 32.765)
- 6931: SP#43 completed / Impacted TSs and TRs: new 32.425
- 6932: SP#43 completed / Impacted TSs and TRs: new (32.450; 32.451)

| ID | WBS | Task | Duration | Start | Finish | Complete | Baseline start | Baseline finish | Baseline duration | Constraint | Resources | Work | Actual work | Acronym | PCG approved | WI rapporteur name | WI rapporteur e-mail | Release | TSG approved | MCC resp | Special Focus Doc | Acronym_3GU_Export | Status Report | PCG stopped | TSG stopped |
| --- | --- | --- | --- | --- | --- | --- | --- | --- | --- | --- | --- | --- | --- | --- | --- | --- | --- | --- | --- | --- | --- | --- | --- | --- | --- |
| 6933 | 2187.7 | **Self-Organizing Networks (SON)** | 210d? | 2008-02-22 A | 2008-12-11 A | 100% | 2008-02-22 | 2008-12-11 | 210d? |  | S5 | 6720h | 6720h | LTE_SON-OAM | 21 | Vodafone | GOMPAKIS, Panagiotis | Rel-8 | 39 | Mirko | SON | LTE_SON-OAM |  |  |  |
| 6934 | 2187.7.1 | SON Concepts and requirements | 210d? | 2008-02-22 A | 2008-12-11 A | 100% | 2008-02-22 | 2008-12-11 | 210d? |  | S5 | 1680h | 1680h | LTE_SON-OAM | 21 | Vodafone | GOMPAKIS, Panagiotis | Rel-8 | 39 | Mirko |  |  |  |  |  |
| 6935 | 2187.7.2 | Self-Establishment of eNBs, including automated Software Management | 210d? | 2008-02-22 A | 2008-12-11 A | 100% | 2008-02-22 | 2008-12-11 | 210d? | start no earlier than 2008-02-22 | S5 | 1680h | 1680h | LTE_SON-OAM | 21 | Nokia Siemens Networks | SUERBAUM, Clemens | Rel-8 | 39 | Mirko |  |  |  |  |  |
| 6936 | 2187.7.3 | SON Automatic Neighbour Relations (ANR) List Management | 210d? | 2008-02-22 A | 2008-12-11 A | 100% | 2008-02-22 | 2008-12-11 | 210d? | finish no earlier than 2008-12-11 | S5 | 1680h | 1680h | LTE_SON-OAM | 21 | Ericsson | edwin.tse@ericsson.com | Rel-8 | 39 | Mirko |  |  |  |  |  |
| 6937 | 2188 | **Rel-8 LTE – Terminal Conformance Test Specification** | 657d? | 2007-06-01 A | 2009-12-04 A | 100% | 2007-06-01 | 2009-12-04 | 657d? |  | R5 | 14336h | 14336h | LTE-UEConTest |  |  |  | Rel-8 |  | Ingbert |  | LTE-UEConTest |  |  |  |
| 6938 | 2188.1 | 3G LTE – Terminal Protocol Conformance Test Specifications | 657d? | 2007-06-01 A | 2009-12-04 A | 100% | 2007-06-01 | 2009-12-04 | 657d? | finish no earlier than 2009-12-04 | R5 | 5256h | 5256h | LTE-UEConTest_SIG |  | NEC, Motorola | david.lecompte@nectech.fr, Jacob.John@motorola.com | Rel-8 |  | Ingbert |  | LTE-UEConTest_SIG | RP-091060 |  |  |
| 6939 | 2188.2 | LTE – Terminal Radio Transmission and Reception Conformance Test Specifications | 657d? | 2007-06-01 A | 2009-12-04 A | 100% | 2007-06-01 | 2009-12-04 | 657d? |  | R5 | 5256h | 5256h | LTE-UEConTest_RF |  | Agilent | andrea_leonardi@agilent.com | Rel-8 |  | Ingbert |  | LTE-UEConTest_RF | RP-091059 |  |  |
| 6940 | 2189 | **Rel-8 Improvements of the Radio Interface** | 525d? | 2007-03-05 A | 2009-03-06 A | 100% | 2007-03-05 | 2009-03-06 | 525d? |  | RP | 18152h | 18152h | RInImp8 |  |  |  | Rel-8 |  | Issam |  | RInImp8 |  |  |  |
| 6941 | 2189.1 | UMTS 1500 MHz | 140d? | 2007-03-05 A | 2007-09-14 A | 100% | 2007-03-05 | 2007-09-14 | 140d? | finish no earlier than 2007-09-14 | R4 | 1120h | 1120h | RInImp8-UMTS1500 |  | NTT DoCoMo | Takehiro Nakamura (nakamurata@nttdocomo.co.jp) | Rel-8 |  | Issam |  | RInImp8-UMTS1500 | RP-070526 |  |  |
| 6942 | 2189.2 | UMTS 700 MHz FDD | 325d? | 2007-03-05 A | 2008-05-30 A | 100% | 2007-03-05 | 2008-05-30 | 325d? | finish no earlier than 2008-06-12 | R4 | 2600h | 2600h | RInImp8-UMTS700 |  | Nokia | Tuomo Saynajakangas | Rel-8 |  | Issam |  | RInImp8-UMTS700 | RP-080260 |  |  |
| 6943 | 2189.3 | UMTS 1880 MHz TDD | 126d? | 2008-09-12 A | 2009-03-06 A | 100% | 2008-09-12 | 2009-03-06 | 126d? | finish no earlier than 2009-03-09 | R4 | 1008h | 1008h | RInImp9-UMTS1880TDD | 21 | CATT | Yuexia Song (songyuexia@catt.cn) | Rel-8 | 41 | Issam |  | RInImp9-UMTS1880TDD | RP-090044 |  |  |
| 6944 | 2189.4 | UMTS 2300 MHz TDD LCR | 195d? | 2007-12-17 A | 2008-09-12 A | 100% | 2007-12-17 | 2008-09-12 | 195d? | finish no earlier than 2008-09-12 | R4 | 1560h | 1560h | RInImp8-UMTS2300TDD | 21 | CATT | Yuexia Song (songyuexia@catt.cn) | Rel-8 | 38 | Issam |  | RInImp8-UMTS2300TDD | RP-080517 |  |  |
| 6945 | 2189.5 | Further Improved Minimum Performance Requirements for HSDPA UE (FDD) - Two-Branch Interference Cancellation | 265d? | 2007-03-05 A | 2008-03-07 A | 100% | 2007-03-05 | 2008-03-07 | 265d? | finish no earlier than 2008-03-12 | R4 | 2120h | 2120h | RInImp8-2BIC |  | AT&T | Marc Grant | Rel-8 |  | Issam |  | RInImp8-2BIC | RP-080041 |  |  |
| 6946 | 2189.6 | CS Voice Service over HSPA | 167d? | 2007-07-19 A | 2008-03-07 A | 100% | 2007-07-19 | 2008-03-07 | 167d? |  | R2 | 1336h | 1336h | RInImp8-CsHspa |  | Nokia Siemens Networks | woonhee.hwang@nsn.com | Rel-8 | 37 | Yong-Jun |  | RInImp8-CsHspa | RP-080042 |  |  |
| 6947 | 2189.7 | Performance requirements for 15 code reception with 16QAM/QPSK (FDD) | 126d? | 2007-06-11 A | 2008-03-07 A | 100% | 2007-06-11 | 2008-03-07 | 126d? | finish no earlier than 2008-06-12 | R4 | 1008h | 1008h | RInImp8-Hsdpa15codes |  | Vodafone | tim.frost@vodafone.com | Rel-8 | 37 | Issam |  | RInImp8-Hsdpa15codes | RP-080043 |  |  |
| 6948 | 2189.8 | Deleted - UMTS 2300 MHz FDD/TDD | 400d? | 2007-03-05 A | 2008-09-12 A | 100% | 2007-03-05 | 2008-09-12 | 400d? | finish no earlier than 2008-12-11 | R4 | 3200h | 3200h | RInImp8-UMTS2300 |  | AT&T | Marc Grant | Rel-8 |  | Issam |  | RInImp8-UMTS2300 | RP-080515 | PCG-21 | RP-41 |
| 6949 | 2190 | **Rel-8 Improvements of the Radio Interface - UE Conformance Testing** | 396d? | 2007-06-01 A | 2008-12-05 A | 100% | 2007-06-01 | 2008-12-05 | 396d? |  | R5 | 6256h | 6256h |  |  |  |  | Rel-8 |  | Ingbert |  |  |  |  |  |
| 6950 | 2190.1 | Conformance Test Aspects – CS Voice Service over HSPA | 336d? | 2007-06-01 A | 2008-09-12 A | 100% | 2007-06-01 | 2008-09-12 | 336d? | finish no earlier than 2008-09-12 | R5 | 2688h | 2688h | RInImp8-CsHspa_UEConTest |  | Huawei | baoyi@huawei.com | Rel-8 |  | Ingbert |  | RInImp8-CsHspa_UEConTest | RP-080542 |  |  |
| 6951 | 2190.2 | Conformance Test Aspects – Performance requirements for 15 code reception with 16QAM/QPSK (FDD) | 195d? | 2008-03-07 A | 2008-12-05 A | 100% | 2008-03-07 | 2008-12-05 | 195d? | finish no earlier than 2008-12-05 | R5 | 1560h | 1560h | RInImp8-UEConTest_Hsdpa15codes | 21 | Ericsson | Mikael.Ziren@Ericsson.com | Rel-8 | 40 | Ingbert |  | RInImp8-UEConTest_ Hsdpa15codes | RP-080818 |  |  |
| 6952 | 2191 | **Rel-8 RAN improvements** | 520d? | 2007-06-04 A | 2009-05-29 A | 100% | 2007-06-04 | 2009-05-29 | 520d? |  | RP | 37481.6h | 37481.6h |  |  |  |  | Rel-8 |  |  |  |  |  |  |  |
| 6953 | 2191.1 | Combination of 64QAM and MIMO for HSDPA (FDD) | 205d? | 2007-06-04 A | 2008-09-12 A | 100% | 2007-06-04 | 2008-09-12 | 205d? | finish no earlier than 2008-09-12 | R1 | 1640h | 1640h | RANimp-64QamMimoHsdpa |  | Ericsson | Johan.Bergman@ericsson.com | Rel-8 |  | Patrick |  | RANimp-64QamMimoHsdpa | RP-080518 |  |  |
| 6954 | 2191.2 | Improved L2 for uplink | 186d? | 2007-09-14 A | 2008-05-30 A | 100% | 2007-09-14 | 2008-05-30 | 186d? | finish no earlier than 2008-05-30 | R2 | 1488h | 1488h | RANimp-UplinkL2dataRates |  | Ericsson | Janne.Peisa@ericsson.com | Rel-8 | 37 | Yong-Jun |  | RANimp-UplinkL2dataRates | RP-080265 |  |  |
| 6955 | 2191.3 | Enhanced Uplink for CELL_FACH State in FDD | 321d? | 2007-09-14 A | 2008-12-05 A | 100% | 2007-09-14 | 2008-12-05 | 321d? | finish no earlier than 2008-12-12 | R2 | 2568h | 2568h | RANimp-UplinkEnhState |  | Nokia Siemens Networks | markus.wimmer@nsn.com | Rel-8 | 37 | Yong-Jun |  | RANimp-UplinkEnhState | RP-080804 |  |  |
| 6956 | 2191.4 | Enhanced UE Discontinuous Reception (DRX) for FDD | 261d? | 2007-09-14 A | 2008-09-12 A | 100% | 2007-09-14 | 2008-09-12 | 261d? | finish no earlier than 2008-09-12 | R2 | 2088h | 2088h | RANimp-DRX |  | Nokia | luis.barreto@nokia.com | Rel-8 | 37 | Yong-Jun |  | RANimp-DRX | RP-080520 |  |  |
| 6957 | 2191.5 | Enhancements for Serving Radio Network Subsystem (SRNS) Relocation Procedure | 261d? | 2007-09-14 A | 2008-09-12 A | 100% | 2007-09-14 | 2008-09-12 | 261d? | finish no earlier than 2008-09-12 | R3 | 2088h | 2088h | RANimp-SrnsReloc |  | Nokia Siemens Networks | masatoshi.nakamata@nsn.com | Rel-8 | 37 | Juha |  | RANimp-SrnsReloc | RP-080521 |  |  |
| 6958 | 2191.6 | Enhancements for FDD HSPA Evolution | 321d? | 2007-09-14 A | 2008-12-05 A | 100% | 2007-09-14 | 2008-12-05 | 321d? | finish no earlier than 2008-12-05 | R3; R2 | 5136h | 5136h | RANimp-HSPAEvo |  | Nokia Siemens Networks | masatoshi.nakamata@nsn.com | Rel-8 | 37 | Juha |  | RANimp-HSPAEvo | RP-080805 |  |  |
| 6959 | 2191.7 | 64QAM for 1.28 Mcps TDD HSDPA | 264d? | 2007-12-04 A | 2008-12-05 A | 100% | 2007-12-04 | 2008-12-05 | 264d? | finish no earlier than 2008-12-05 | R1 | 2112h | 2112h | RANimp-64Qam1.28TDD | 21 | ZTE | zfmail@zte.com.cn | Rel-8 | 38 | Patrick |  | RANimp-64Qam1.28TDD | RP-080806 |  |  |
| 6960 | 2191.8 | Enhanced CELL_FACH state in 1.28 Mcps TDD | 264d? | 2007-12-04 A | 2008-12-05 A | 100% | 2007-12-04 | 2008-12-05 | 264d? | finish no earlier than 2008-12-12 | R2 | 2112h | 2112h | RANimp-EnhState1.28TDD | 21 | ZTE | zhang.yincheng@zte.com.cn | Rel-8 | 38 | Yong-Jun |  | RANimp-EnhState1.28TDD | RP-080807 |  |  |
| 6961 | 2191.9 | Continuous Connectivity for packet data users for 1.28 Mcps TDD | 321d? | 2008-03-07 A | 2009-05-29 A | 100% | 2008-03-07 | 2009-05-29 | 321d? | finish no earlier than 2009-05-29 | R1 | 2568h | 2568h | RANimp-LCRCPC | 21 | TD Tech | chenying@td-tech.com | Rel-8 | 39 | Patrick |  | RANimp-LCRCPC | RP-090394 |  |  |
| 6962 | 2191.10 | HSPA VoIP to WCDMA/GSM CS continuity | 261d? | 2008-03-07 A | 2009-03-06 A | 100% | 2008-03-07 | 2009-03-06 | 261d? | finish no earlier than 2009-03-06 | R2 | 2088h | 2088h | RANimp-HSPAVoIP | 21 | Nokia | Simone.Provvedi@nokia.com | Rel-8 | 39 | Yong-Jun |  | RANimp-HSPAVoIP | RP-090050 |  |  |
| 6963 | 2191.11 | HS-DSCH Serving Cell Change Enhancements | 196d? | 2008-03-07 A | 2008-12-05 A | 100% | 2008-03-07 | 2008-12-05 | 196d? | finish no earlier than 2008-12-12 | R2 | 1568h | 1568h | RANimp-HSDSCH | 21 | Ericsson | henrik.enbuske@ericsson.com | Rel-8 | 39 | Yong-Jun |  | RANimp-HSDSCH | RP-080811 |  |  |
| 6964 | 2191.12 | MIMO for 1.28 Mcps TDD. Linked to Rel-8 Study on Scope of future HSPA Evolution for 1.28 Mcps TDD (UID_370041) TR 25.824 | 351.6d? | 2008-01-24 A | 2009-05-29 A | 100% | 2008-01-24 | 2009-05-29 | 351.6d? | finish no earlier than 2009-05-29 | R1; R4 | 5625.6h | 5625.6h | RANimp-MIMOLCR | 21 | CATT | wangke@datangmobile.cn | Rel-8 | 40 | Patrick |  | RANimp-MIMOLCR | RP-090313 |  |  |
| 6965 | 2191.13 | Dual-Cell HSDPA operation on adjacent carriers | 140d? | 2008-11-17 A | 2009-05-29 A | 100% | 2008-11-17 | 2009-05-29 | 140d? | finish no earlier than 2009-05-29 | R1; R4 | 2240h | 2240h | RANimp-DCHSDPA | 21 | Ericsson | johan.bergman@ericsson.com | Rel-8 | 40 | Patrick |  | RANimp-DCHSDPA | RP-080814 |  |  |

Notes:
- 6933: SP#42 completed (WT UID_390007 moved to Rel-9)
- 6934: SP#42 completed / Impacted TSs and TRs: new 32.500
- 6935: SP#42 completed / Impacted TSs and TRs: new (32.501; 32.502; 32.503; 32.531; 32.532; 32.533)
- 6936: SP#42 completed / Impacted TSs and TRs: 32.761; 32.762; 32.763; 32.765; new 32.511
- 6937: Testing for Feature UID_20068 (LTE)
- 6938: RP#46 completed / Impacted TSs and TRs: 36.521-1; 36.521-2; 36.508; 36.509; 36.523-1; 36.523-2; 36.523-3
- 6939: RP#46 completed. RP#50 TR 36.903 v100 for Approval / Impacted TSs and TRs: 36.521-1; 36.521-2; 36.521-3; new 36.903
- 6940: -
- 6941: RP#37 completed / Impacted TSs and TRs: 25.101; 25.104; 25.133; 25.141; 25.331; 25.942; 25.306; 25.307; 34.121
- 6942: RP#40 completed / Impacted TSs and TRs: 25.101; 25.104; 25.133; 25.141; 25.331; 25.942; 25.306; 25.307; 34.121
- 6943: RP#43 completed / Impacted TSs and TRs: 25.102; 25.105; 25.113; 25.123; 25.142; 34.124; 25.307
- 6944: RP#41 completed. RP#47 abandoned draft 25.828 / Impacted TSs and TRs: 25.102; 25.105; 25.113; 25.123; 25.142; 34.124; 25.306; 25.331; 34.122
- 6945: RP#39 completed / Impacted TSs and TRs: 25.101
- 6946: RP#39 completed / Impacted TSs and TRs: 25.323; 25.331; 25.322
- 6947: RP#39 completed / Impacted TSs and TRs: 25.101
- 6948: RP#41 stopped / Impacted TSs and TRs: 25.101; 25.104; 25.133; 25.141; 25.331; 25.942; 25.306; 25.307; 34.121
- 6949: 05/08: Linked to Feature UID_20028 (RInImp)
- 6950: RP#41 completed / Impacted TSs and TRs: 34.108; 34.123-1; 34.123-2; 34.123-3
- 6951: RP#42 completed / Impacted TSs and TRs: 34.121-1; 34.121-2
- 6952: -
- 6953: RP#41 completed / Impacted TSs and TRs: 25.308; 25.211; 25.212; 25.213; 25.306; 25.331; 25.433; 25.435; 25.423; 25.425; 25.101; 25.104; 25.141
- 6954: RP#40 completed. Linked to UID_370037 Enhanced Uplink for CELL_FACH State in FDD / Impacted TSs and TRs: 25.319; 25.301; 25.306; 25.321; 25.331; 25.433; 25.435; 25.423; 25.425; 25.427
- 6955: RP#42 completed. Linked to UID_370036 Improved L2 for uplink / Impacted TSs and TRs: 25.309; 25.211; 25.214; 25.321; 25.331; 25.423; 25.433
- 6956: RP#41 completed. Continuation of Rel-7 work item "Continuous connectivity for packet data users" UID_20046. / Impacted TSs and TRs: 25.306; 25.308; 25.321; 25.331; 25.423
- 6957: RP#41 completed. Linked to UID_370040 Enhancements for FDD HSPA Evolution / Impacted TSs and TRs: 25.306; 25.308; 25.321; 25.331; 25.423; 25.433; 25.214; 25.133
- 6958: RP#42 completed. Triggered by Rel-7 Study on Scope of future FDD HSPA Evolution (UID_20065) TR 25.999 / Impacted TSs and TRs: 25.401; 25.413; 25.420; 25.423; 25.427; 25.433; 25.446; 25.301; 25.346
- 6959: RP#42 completed. Linked to Rel-8 Study on Scope of future HSPA Evolution for 1.28 Mcps TDD (UID_370041) TR 25.824 / Impacted TSs and TRs: 25.102; 25.105; 25.123; 25.142; 25.201; 25.221; 25.222; 25.223; 25.224; 25.306; 25.308; 25.321; 25.331; 25.423; 25.433
- 6960: RP#42 completed. Linked to Rel-8 Study on Scope of future HSPA Evolution for 1.28 Mcps TDD (UID_370041) TR 25.824 / Impacted TSs and TRs: 25.123; 25.221; 25.222; 25.224; 25.301; 25.302; 25.304; 25.306; 25.308; 25.319; 25.321; 25.331; 25.401; 25.423; 25.425; 25.433; 25.435
- 6961: RP#44 completed. Linked to Rel-8 Study on Scope of future HSPA Evolution for 1.28 Mcps TDD (UID_370041) TR 25.824 / Impacted TSs and TRs: 25.929; 25.308; 25.319
- 6962: RP#43 completed / Impacted TSs and TRs: 25.331; 25.413
- 6963: RP#42 completed / Impacted TSs and TRs: 25.101; 25.104; 25.133; 25.212; 25.214; 25.308; 25.321; 25.331; 25.423; 25.433
- 6964: RP#43 completed / Impacted TSs and TRs: 25.201; 25.221; 25.222; 25.223; 25.224; 25.306; 25.308; 25.321; 25.331; 25.423; 25.433; 25.102; 25.105; 25.142
- 6965: RP#42 completed. Triggered by UID_390032 Study on Dual-Cell HSDPA (withdrawn TR 25.825 v100). / Impacted TSs and TRs: 25.101; 25.104; 25.133; 25.141; 25.211; 25.212; 25.213; 25.214; 25.215; 25.306; 25.308; 25.321; 25.331; 25.423; 25.433

| ID | WBS | Task | Duration | Start | Finish | Complete | Baseline start | Baseline finish | Baseline duration | Constraint | Resources | Work | Actual work | Release | MCC resp | Acronym | PCG approved | WI rapporteur name | TSG approved | Status Report | Acronym_3GU_Export |
| --- | --- | --- | --- | --- | --- | --- | --- | --- | --- | --- | --- | --- | --- | --- | --- | --- | --- | --- | --- | --- | --- |
| 6966 | 2192 | **Rel-8 RAN improvements - UE Conformance Testing** | 602d? | 2008-05-30 A | 2010-09-17 A | 100% | 2008-05-30 | 2010-09-17 | 602d? |  | R5 | 29391.2h | 29391.2h | Rel-8 | Ingbert |  |  |  |  |  |  |
| 6967 | 2192.1 | Conformance Test Aspects – Combination of 64QAM and MIMO for HSDPA (FDD) | 322d? | 2008-09-12 A | 2009-12-04 A | 100% | 2008-09-12 | 2009-12-04 | 322d? | finish no earlier than 2009-12-04 | R5 | 2576h | 2576h | Rel-8 | Ingbert | RANimp-UEConTest_64QamMimoHsdpa | 21 | Ericsson | 41 | RP-091058 | RANimp-UEConTest_64QamMimoHsdpa |
| 6968 | 2192.2 | Conformance Test Aspects – Improved L2 for uplink | 341d? | 2008-05-30 A | 2009-09-18 A | 100% | 2008-05-30 | 2009-09-18 | 341d? | finish no earlier than 2009-09-18 | R5 | 2728h | 2728h | Rel-8 | Ingbert | RANimp-UEConTest_UplinkL2dataRates | 21 | Ericsson | 40 | RP-090712 | RANimp-UEConTest_UplinkL2dataRates |
| 6969 | 2192.3 | Conformance Test Aspects – 1.28 Mcps TDD Improved L2 support for high data rates | 342d? | 2009-05-29 A | 2010-09-17 A | 100% | 2009-05-29 | 2010-09-17 | 342d? | finish no earlier than 2010-09-17 | R5 | 2736h | 2736h | Rel-8 | Ingbert | RANimp-UEConTest_ImprovedL2LCRTDD | 23 | CATT | 44 | RP-100737 | RANimp-UEConTest_ImprovedL2LCRTDD |
| 6970 | 2192.4 | Conformance Test Aspects – 64QAM for 1.28 Mcps TDD HSDPA | 261d? | 2008-05-30 A | 2009-05-29 A | 100% | 2008-05-30 | 2009-05-29 | 261d? | finish no earlier than 2009-05-29 | R5 | 2088h | 2088h | Rel-8 | Ingbert | RANimp-UEConTest_64Qam1.28TDD | 21 | ZTE | 40 | RP-090415 | RANimp-UEConTest_64Qam1.28TDD |
| 6971 | 2192.5 | Conformance Test Aspects – Dual-Cell HSDPA operation on adjacent carriers | 391d? | 2008-12-05 A | 2010-06-04 A | 100% | 2008-12-05 | 2010-06-04 | 391d? | finish no earlier than 2010-06-04 | R5 | 3128h | 3128h | Rel-8 | Ingbert | RANimp-UEConTest_DCHSDPA | 22 | Qualcomm | 42 | RP-100479 | RANimp-UEConTest_DCHSDPA |
| 6972 | 2192.6 | Conformance Test Aspects – Enhanced Uplink for CELL_FACH State in FDD | 326d? | 2009-03-06 A | 2010-06-04 A | 100% | 2009-03-06 | 2010-06-04 | 326d? | finish no earlier than 2010-06-04 | R5 | 2608h | 2608h | Rel-8 | Ingbert | RANimp-UEConTest_EnhancedRACHCellFACHState | 22 | Nokia | 43 | RP-100483 | RANimp-UEConTest_EnhancedRACHCellFACHState |
| 6973 | 2192.7 | Conformance Test Aspects – Receiver Type3i | 196d? | 2009-03-06 A | 2009-12-04 A | 100% | 2009-03-06 | 2009-12-04 | 196d? | finish no earlier than 2009-12-04 | R5 | 1568h | 1568h | Rel-8 | Ingbert | RANimp-UEConTest_ReceiverType3i | 22 | Qualcomm | 43 | RP-091066 | RANimp-UEConTest_ReceiverType3i |
| 6974 | 2192.8 | Conformance Test Aspects – Enhanced CELL_FACH State in LCR TDD | 341d? | 2009-05-30 A | 2010-09-17 A | 100% | 2009-05-30 | 2010-09-17 | 341d? | finish no earlier than 2010-09-17 | R5 | 2728h | 2728h | Rel-8 | Ingbert | RANimp-UEConTest_EnhancedCellFACHStateLCRTDD | 23 | CATT | 44 | RP-100735 | RANimp-UEConTest_EnhancedCellFACHStateLCRTDD |
| 6975 | 2192.9 | Conformance Test Aspects – Continuous Connectivity for packet data users for 1.28 Mcps TDD | 261d? | 2009-09-18 A | 2010-09-17 A | 100% | 2009-09-18 | 2010-09-17 | 261d? | finish no earlier than 2010-09-17 | R5 | 2088h | 2088h | Rel-8 | Ingbert | RANimp-UEConTest_CPCLCRTDD | 23 | ZTE | 45 | RP-100739 | RANimp-UEConTest_CPCLCRTDD |
| 6976 | 2192.10 | Conformance Test Aspects – MIMO for 1.28 Mcps TDD | 186d? | 2009-09-18 A | 2010-06-04 A | 100% | 2009-09-18 | 2010-06-04 | 186d? | finish no earlier than 2010-06-04 | R5 | 1488h | 1488h | Rel-8 | Ingbert | RANimp-UEConTest_MIMOLCRTDD | 23 | ZTE | 45 | RP-100660 | RANimp-UEConTest_MIMOLCRTDD |
| 6977 | 2192.11 | Conformance Test Aspects – HS-DSCH Serving Cell Change Enhancements | 131d? | 2009-09-18 A | 2010-03-19 A | 100% | 2009-09-18 | 2010-03-19 | 131d? | finish no earlier than 2010-03-12 | R5 | 1048h | 1048h | Rel-8 | Ingbert | HSDSCH_UEConTest | 23 | Qualcomm | 45 | RP-100077 | HSDSCH_UEConTest |
| 6978 | 2193 | 3.84 Mcps TDD MBMS over a Single Frequency Network (MBSFN) Integrated Mobile Broadcast | 395d? | 2007-06-04 A | 2008-12-05 A | 100% | 2007-06-04 | 2008-12-05 | 395d? |  | R1 | 3160h | 3160h | Rel-8 | Patrick | MBSFN-DOB |  | Ericsson |  | RP-080218 | MBSFN-DOB |
| 6979 | 2194 | Conformance Test Aspects – 3.84 Mcps TDD MBMS over a Single Frequency Network (MBSFN) Integrated Mobile Broadcast | 211d? | 2009-05-30 A | 2010-03-19 A | 100% | 2009-05-30 | 2010-03-19 | 211d? | finish no earlier than 2010-03-19 | R5 | 1688h | 1688h | Rel-8 | Ingbert | MBSFN_IMB_UEConTest | 23 | IPwireless | 44 | RP-100070 | MBSFN_IMB_UEConTest |
| 6980 | 2195 | **GERAN support for GERAN - 3G Long Term Evolution interworking** | 1365d? | 2006-09-08 A | 2011-11-25 A | 100% | 2006-09-08 | 2011-11-25 | 1365d? |  | GP; G1; C1; G3new | 69960h | 69960h | Rel-8 | Paolo | GELTE |  | Nokia, Nokia Siemens Networks |  |  | GELTE |
| 6981 | 2195.1 | G1 part of GERAN support for GERAN - 3G Long Term Evolution interworking | 641d? | 2006-09-08 A | 2009-02-20 A | 100% | 2006-09-08 | 2009-02-20 | 641d? | finish no earlier than 2009-02-20 | G1 | 5128h | 5128h | Rel-8 | Paolo | GELTE |  | Nokia, Nokia Siemens Networks |  |  |  |
| 6982 | 2195.2 | G2 part of GERAN support for GERAN - 3G Long Term Evolution interworking | 641d? | 2006-09-08 A | 2009-02-20 A | 100% | 2006-09-08 | 2009-02-20 | 641d? | finish no earlier than 2009-02-20 | G2 | 5128h | 5128h | Rel-8 | Paolo | GELTE |  | Nokia, Nokia Siemens Networks |  |  |  |
| 6983 | 2195.3 | CT1 part of GERAN support for GERAN - 3G Long Term Evolution interworking | 641d? | 2006-09-08 A | 2009-02-20 A | 100% | 2006-09-08 | 2009-02-20 | 641d? | finish no earlier than 2009-02-20 | C1 | 5128h | 5128h | Rel-8 | Paolo | GELTE |  | Nokia, Nokia Siemens Networks |  |  |  |
| 6984 | 2195.4 | Testing for GERAN support for GERAN - 3G Long Term Evolution interworking | 1363d? | 2006-09-08 A | 2011-11-25 A | 100% | 2006-09-08 | 2011-11-25 | 1363d? | finish no earlier than 2011-11-25 | G3new | 10896h | 10896h | Rel-8 | Ingbert | GELTE |  | Renesas Mobile |  |  |  |
| 6985 | 2196 | U-TDOA Enhancement | 131d? | 2007-05-18 A | 2007-11-16 A | 100% | 2007-05-18 | 2007-11-16 | 131d? | finish no earlier than 2007-05-18 | GP | 1048h | 1048h | Rel-8 | Paolo | GUTEN |  | TruePosition |  |  | GUTEN |
| 6986 | 2197 | **GAN Enhancements** | 604.2d? | 2007-05-15 A | 2009-09-04 A | 100% | 2007-05-15 | 2009-09-04 | 604.2d? |  | GP | 9432h | 9432h | Rel-8 | Paolo | GANENH |  | T-Mobile |  |  | GANENH |
| 6987 | 2197.1 | Update to GAN specifications | 126d? | 2007-08-31 A | 2008-02-22 A | 100% | 2007-08-31 | 2008-02-22 | 126d? | finish no earlier than 2008-02-22 | GP | 1008h | 1008h | Rel-8 | Paolo | GANENH-SPEC |  | T-Mobile |  |  | GANENH-SPEC |
| 6988 | 2197.2 | Update TS 51.010 Mobile Station (MS) Conformance Specification for GAN Enhancements | 526d? | 2007-05-15 A | 2009-09-04 A | 100% | 2007-05-15 | 2009-09-04 | 526d? | finish no earlier than 2009-09-04 | G3new | 4208h | 4208h | Rel-8 | Ingbert | GANENH-MStest |  | T-Mobile |  |  | GANENH-MStest |
| 6989 | 2198 | **AoIP (A-interface over IP)** | 2335d? | 2000-01-03 A | 2008-12-11 A | 100% | 2000-01-03 | 2008-12-11 | 2335d? |  | GP; S4; C4; C1; C3 | 119396h | 119396h | Rel-8 | Paolo | AoIP | 21 | China Mobile, Ericsson |  |  | AoIP |
| 6990 | 2198.1 | GERAN aspects of AoIP | 2321d? | 2000-01-03 A | 2008-11-21 A | 100% | 2000-01-03 | 2008-11-21 | 2321d? | finish no earlier than 2008-11-21 | GP | 18560h | 18560h | Rel-8 | Paolo | AoIP | 21 | China Mobile, Ericsson | 40 |  |  |
| 6991 | 2198.2 | Media Requirements for CS over IP based User Plane | 267d? | 2007-12-05 A | 2008-12-11 A | 100% | 2007-12-05 | 2008-12-11 | 267d? | finish no earlier than 2008-12-11 | S4 | 1996.09h | 1996.09h | Rel-8 | Paolo | AoIP-CSoIP | 21 | China Mobile, Ericsson | 40 |  | AoIP-CSoIP |

Notes:
- 6966: Linked to Feature UID_20029 (RANimp)
- 6967: RP#46 completed. Testing for UID_360013 / Impacted TSs and TRs: 34.108; 34.121-1; 34.121-2; 34.123-1; 34.123-2 / WI rapporteur e-mail: leif.mattisson@ericsson.com
- 6968: RP#45 completed. Testing for UID_370036 / Impacted TSs and TRs: 34.108; 34.123-1; 34.123-2; 34.123-3 / WI rapporteur e-mail: leif.mattisson@ericsson.com
- 6969: RP#49 completed. Testing for Rel-7 UID_340039 Improved L2 support for high data rates and Rel-8 UID_370036 Improved L2 for uplink / Impacted TSs and TRs: 34.108; 34.123-1; 34.123-2; 34.123-3 / WI rapporteur e-mail: Xiaozhong Chen (chenxiaozhong@datangmobile.cn)
- 6970: RP#44 completed. Testing for UID_380075 / Impacted TSs and TRs: 34.108; 34.122; 34.123-1; 34.123-2; 34.123-3 / WI rapporteur e-mail: ma.zijiang@zte.com.cn
- 6971: RP#48 completed. Testing for UID_400052 / Impacted TSs and TRs: 34.108; 34.121-1; 34.121-2; 34.123-1; 34.123-2; 34.123-3 / WI rapporteur e-mail: Shubhang Vora (svora@qualcomm.com)
- 6972: RP#48 completed. Testing for UID_370037 / Impacted TSs and TRs: 34.108; 34.121-1; 34.121-2; 34.123-1; 34.123-2; 34.123-3 / WI rapporteur e-mail: jarkko.hellsten@nokia.com
- 6973: RP#46 completed. Testing for Receiver Type3i in 25.101 UE radio Tx and Rx FDD / Impacted TSs and TRs: 34.108; 34.121-1; 34.121-2 / WI rapporteur e-mail: Ashok Kumar Narayanaswamy (anarayan@qualcomm.com)
- 6974: RP#49 completed. Testing for UID_380076 / Impacted TSs and TRs: 34.108; 34.123-1; 34.123-2; 34.123-3 / WI rapporteur e-mail: Xiaozhong Chen (chenxiaozhong@datangmobile.cn)
- 6975: RP#49 completed. Testing for UID_390028 / Impacted TSs and TRs: 34.108; 34.123-1; 34.123-2; 34.123-3 / WI rapporteur e-mail: huang.he4@zte.com.cn
- 6976: PR#48 completed. Testing for UID_400050 / Impacted TSs and TRs: 34.108; 34.122; 34.123-1; 34.123-2; 34.123-3 / WI rapporteur e-mail: huang.chun2@zte.com.cn
- 6977: RP#47 completed. Testing for UID_390030 / Impacted TSs and TRs: 34.108; 34.121-1; 34.121-2; 34.123-1; 34.123-2; 34.123-3 / WI rapporteur e-mail: Shubhang Vora (svora@qualcomm.com)
- 6978: RP#42 completed. WID updated RP-070493=>RP-081124 (changed WI title "MBSFN Downlink Optimized Broadcast (DOB) 3.84 Mcps TDD" => "3.84Mcps TDD MBSFN Integrated Mobile Broadcast"). / Impacted TSs and TRs: 25.102; 25.105; 25.123; 25.201; 25.221; 25.222; 25.223; 25.224; 25.304; 25.306; 25.331; 25.346; 25.402; 25.433 / WI rapporteur e-mail: Lars.Lindbom@ericsson.com
- 6979: RP#47 completed. Testing for Rel-8 MBSFN-DOB UID_360008 / Impacted TSs and TRs: 34.108; 34.122; 34.123-1; 34.123-2; 34.123-3 / WI rapporteur e-mail: Phil Young (pyoung@ipwireless.com)
- 6980: GP#41 completed. GP#52 completed MS conformance testing / Impacted TSs and TRs: 44.018; 44.060; 45.002; 45.008; 45.010; 48.008; 48.018; 51.010 / WI rapporteur e-mail: sergio.parolari@nsn.com, vlora.rexhepi@nokia.com
- 6981: GP#41 completed / Impacted TSs and TRs: 43.055; 43.129; 43.246; 45.002; 45.008; 45.010 / WI rapporteur e-mail: sergio.parolari@nsn.com, vlora.rexhepi@nokia.com
- 6982: GP#41 completed / Impacted TSs and TRs: 44.018; 44.060; 48.008; 48.018 / WI rapporteur e-mail: sergio.parolari@nsn.com, vlora.rexhepi@nokia.com
- 6983: - / Impacted TSs and TRs: 24.008 / WI rapporteur e-mail: sergio.parolari@nsn.com, vlora.rexhepi@nokia.com
- 6984: GP#52 completed / Impacted TSs and TRs: 51.010 / WI rapporteur e-mail: deepa.kamath@renesasmobile.com
- 6985: GP#36 completed U-TDOA (Uplink Time Difference of Arrival) / Impacted TSs and TRs: 43.059; 45.008; 48.071 / WI rapporteur e-mail: Terry Brooks (terri.brooks@trueposition.com)
- 6986: GP#37 completed. GP#43 completed Testing / WI rapporteur e-mail: mohammed.versi@t-mobile.com
- 6987: GP#37 completed / Impacted TSs and TRs: 43.318; 44.318 / WI rapporteur e-mail: mohammed.versi@t-mobile.com
- 6988: GP#43 completed / Impacted TSs and TRs: 51.010 / WI rapporteur e-mail: mohammed.versi@t-mobile.com
- 6989: GP#40/TSG#42 completed . Triggered by TR 43.903 Study on A-interface over IP (AINTIP) UID_50589. / WI rapporteur e-mail: wangshuaiyu@chinamobile.com, paul.schliwa-bertling@ericsson.com
- 6990: GP#40 completed. GP#39 updated WID GP-080901=>GP-081362. / Impacted TSs and TRs: 48.001; 48.002; 48.008; 48.020; 49.008; 48.103 / WI rapporteur e-mail: wangshuaiyu@chinamobile.com, paul.schliwa-bertling@ericsson.com
- 6991: SP#42 completed / Impacted TSs and TRs: 26.102; 26.103; 26.202 / WI rapporteur e-mail: Karl.Hellwig@Ericsson.com

| ID | WBS | Task | Type | Duration | Start | Finish | Complete | Baseline start | Baseline finish | Baseline duration | Constraint | Resources | Work | Actual work | Acronym | PCG approved | WI rapporteur name | Release | TSG approved | MCC resp | Acronym_3GU_Export | Impacted TSs and TRs | Status Report | TSG stopped | Special Focus Doc | PCG stopped |
| --- | --- | --- | --- | --- | --- | --- | --- | --- | --- | --- | --- | --- | --- | --- | --- | --- | --- | --- | --- | --- | --- | --- | --- | --- | --- | --- |
| 6992 | 2198.3 | **Core Network Impacts for A-Interface User Plane over IP** |  | 136d? | 2008-05-30 A | 2008-12-05 A | 100% | 2008-05-30 | 2008-12-05 | 136d? |  | C4; C1; C3 | 5440h | 5440h | AoIP-CN | 21 | Ericsson | Rel-8 | 40 | Kimmo | AoIP-CN |  |  |  |  |  |
| 6993 | 2198.3.1 | CT4 part of Core Network Impacts for A-Interface User Plane over IP |  | 136d? | 2008-05-30 A | 2008-12-05 A | 100% | 2008-05-30 | 2008-12-05 | 136d? | start no earlier than 2008-05-30 | C4 | 1088h | 1088h | AoIP-CN | 21 | Ericsson | Rel-8 | 40 | Kimmo |  | 23.205; 23.153; 23.231; 29.232 |  |  |  |  |
| 6994 | 2198.3.2 | CT1 part of Core Network Impacts for A-Interface User Plane over IP |  | 68d? | 2008-05-30 A | 2008-12-05 A | 100% | 2008-05-30 | 2008-12-05 | 68d? | finish no earlier than 2008-12-05 | C1 | 544h | 544h | AoIP-CN | 21 | Ericsson | Rel-8 | 40 | Frederic |  | 23.009 |  |  |  |  |
| 6995 | 2198.3.3 | CT3 part of Core Network Impacts for A-Interface User Plane over IP |  | 68d? | 2008-05-30 A | 2008-12-05 A | 100% | 2008-05-30 | 2008-12-05 | 68d? | finish no earlier than 2008-12-05 | C3 | 544h | 544h | AoIP-CN | 21 | Ericsson | Rel-8 | 40 | Adrian |  | 29.007 |  |  |  |  |
| 6996 | 2199 | New multicarrier BTS class |  | 261d? | 2007-08-31 A | 2008-08-29 A | 100% | 2007-08-31 | 2008-08-29 | 261d? | finish no earlier than 2008-08-29 | G1 | 2088h | 2088h | MCBTS |  | Alcatel-Lucent | Rel-8 |  | Paolo | MCBTS | 45.005; 45.050; 51.021 |  |  |  |  |
| 6997 | 2200 | **Support for Additional Navigation Satellite Systems (ANSS) for LCS** |  | 150d? | 2008-05-16 A | 2008-12-11 A | 100% | 2008-05-16 | 2008-12-11 | 150d? |  | S1; G2; R2 | 5784h | 5784h | ANSS |  | Qualcomm | Rel-8 |  | Paolo | ANSS |  |  |  |  |  |
| 6998 | 2200.1 | Stage 1 for ANSS for LCS |  | 1d? | 2008-12-11 A | 2008-12-11 A | 100% | 2008-12-11 | 2008-12-11 | 1d? | start no earlier than 2008-12-11 | S1 | 8h | 8h | ANSS | 22 |  | Rel-8 | 42 | Alain |  | 22.071 |  |  |  |  |
| 6999 | 2200.2 | GERAN2 part of Support for Additional Navigation Satellite Systems (ANSS) for LCS |  | 136d? | 2008-05-16 A | 2008-11-21 A | 100% | 2008-05-16 | 2008-11-21 | 136d? | start no earlier than 2008-05-16 | G2 | 1088h | 1088h | ANSS |  | Qualcomm | Rel-8 |  | Paolo |  | 43.059; 44.031; 49.031; 44.071; 48.031; 51.010 |  |  |  |  |
| 7000 | 2200.3 | RAN2 part of Support for Additional Navigation Satellite Systems (ANSS) for LCS |  | 136d? | 2008-05-30 A | 2008-12-05 A | 100% | 2008-05-30 | 2008-12-05 | 136d? | finish no earlier than 2008-12-08 | R2 | 1088h | 1088h | RANimp-ANSS | 21 | Qualcomm | Rel-8 | 40 | Yong-Jun | RANimp-ANSS | 25.305; 25.306; 25.331; 25.413; 25.423; 25.433; 25.453 | RP-080813 |  |  |  |
| 7001 | 2201 | **Conformance testing for the Latency Reductions feature** |  | 532d? | 2008-02-22 A | 2010-03-05 A | 100% | 2008-02-22 | 2010-03-05 | 532d? |  | G1; G3new | 14848h | 14848h | CTLATRED | 21 | Ericsson | Rel-8 |  | Paolo | CTLATRED |  |  |  |  |  |
| 7002 | 2201.1 | MS conformance testing for the Latency Reductions feature |  | 532d? | 2008-02-22 A | 2010-03-05 A | 100% | 2008-02-22 | 2010-03-05 | 532d? | finish no earlier than 2010-03-05 | G3new | 4248h | 4248h | CTLATRED-MStest | 21 | Ericsson | Rel-8 |  | Ingbert | CTLATRED-MStest | 51.010 |  |  |  |  |
| 7003 | 2201.2 | BTS conformance testing for the Latency Reductions feature |  | 261d? | 2008-02-22 A | 2009-02-20 A | 100% | 2008-02-22 | 2009-02-20 | 261d? | finish no earlier than 2009-02-20 | G1 | 2088h | 2088h | CTLATRED-BTStest | 21 | Ericsson | Rel-8 |  | Paolo | CTLATRED-BTStest | 51.021 |  |  |  |  |
| 7004 | 2202 | MS conformance testing of changes introduced by WI "Support of Packet-switched Handover for GERAN A/Gb mode" |  | 196d? | 2008-02-22 A | 2008-11-21 A | 100% | 2008-02-22 | 2008-11-21 | 196d? | finish no earlier than 2008-11-21 | G3new | 1568h | 1568h | PSHCT-MStest | 21 | Rohde & Schwarz | Rel-8 |  | Ingbert | PSHCT-MStest | 51.010 |  |  |  |  |
| 7005 | 2203 | (Small) Technical Enhancements and Improvements for Rel-8 |  | 509d? | 2007-01-01 A | 2008-12-11 A | 100% | 2007-01-01 | 2008-12-11 | 509d? | finish no earlier than 2008-12-11 | SP; CP; RP; GP | 16288h | 16288h | TEI8 |  |  | Rel-8 |  | All | TEI8 |  |  |  |  |  |
| 7006 | 2204 | (IETF) (Small) Technical Enhancements and Improvements for Rel-8 |  | 650d? | 2007-01-01 A | 2012-09-07 A | 100% | 2007-01-01 | 2012-09-07 | 650d? | finish no earlier than 2012-09-07 | C1-IETF | 5200h | 5200h | TEI8_IETF | 27 | christer.holmberg@ericsson.com | Rel-8 | 52 | Frederic | TEI8_IETF | RFC 6714 (was draft-ietf-simple-msrp-cema) |  |  |  |  |
| 7007 | 2205 | Test - (Small) Technical Enhancements and Improvements for Rel-8 |  | 993.6d? | 2007-03-07 A | 2010-12-24 A | 100% | 2007-03-07 | 2010-12-24 | 993.6d? | finish no earlier than 2010-12-24 | R5; G3new | 15897.6h | 15897.6h | TEI8_Test | 21 |  | Rel-8 | 40 | Ingbert | TEI8_Test |  |  |  |  |  |
| 7008 | 2206 | **Deleted - All-IP Network** |  | 448d? | 2004-06-28 A | 2006-03-15 A | 100% | 2004-06-28 | 2006-03-15 | 448d? |  | S1 | 7168h | 7168h | AIPN |  | NTT DoCoMo | Rel-8 |  | Alain | AIPN |  |  | SP-38 |  |  |
| 7009 | 2206.1 | Deleted - Stage 1 |  | 448d? | 2004-06-28 A | 2006-03-15 A | 100% | 2004-06-28 | 2006-03-15 | 448d? | finish no earlier than 2006-03-15 | S1 | 3584h | 3584h | AIPN |  | NTT DoCoMo | Rel-8 |  | Alain |  | 22.258 |  | SP-38 |  |  |
| 7010 | 2207 | Deleted - was Rel-7 - LCS for 3GPP Interworking WLAN | milestone | 0d? | 2007-09-28 A | 2007-09-28 A | 100% | 2007-09-28 | 2007-09-28 | 0d? | start no earlier than 2007-09-28 | S2 |  |  | LCS4_IWLAN |  | LG Electronics | Rel-8 | 34 | Maurice | LCS4_IWLAN | 23.234; 23.271; 23.167 |  | SP-35 | WLAN |  |
| 7011 | 2208 | Deleted - never approved- FBI Phase 2 | milestone | 0d | 2007-09-28 A | 2007-09-28 A | 100% | 2007-09-28 | 2007-09-28 | 0d | start no earlier than 2007-09-28 | S2 |  |  | FBI2 |  | Nokia Siemens Networks | Rel-8 |  | Maurice | FBI2 |  |  | SP-38 |  |  |
| 7012 | 2209 | Deleted -Enhancements to BS30 Bearer service for Videotelephony | milestone | 0d? | 2007-03-15 A | 2007-03-15 A | 100% | 2007-03-15 | 2007-03-15 | 0d? | finish no earlier than 2007-03-15 | S1 |  |  | BS30 |  |  | Rel-8 |  | Alain | BS30 | 22.002; 22.004; 22.101; 22.105; 24.008 |  | SP-38 |  |  |
| 7013 | 2210 | Deleted - IMS Enhancements Rel-8 |  | 75d? | 2007-09-03 A | 2007-12-14 A | 100% | 2007-09-03 | 2007-12-14 | 75d? |  | S1 | 600h | 600h | IMS8 |  | Telecom Italia | Rel-8 | 37 | Alain | IMS8 |  |  | SP-38 |  |  |
| 7014 | 2211 | **Deleted - Contact Manager Conformance Test specifications** |  | 471d? | 2008-06-02 A | 2010-03-19 A | 100% | 2008-06-02 | 2010-03-19 | 471d? |  | C6 | 11304h | 11304h | eUPHBOOK-Test | 21 | Comprion, Gemalto | Rel-8 | 40 | Xavier | eUPHBOOK-Test |  |  | CP-47 |  | PCG-24 |
| 7015 | 2211.1 | Deleted - Contact Manager for 3GPP UICC applications test specifications |  | 471d? | 2008-06-02 A | 2010-03-19 A | 100% | 2008-06-02 | 2010-03-19 | 471d? | finish no earlier than 2010-03-19 | C6 | 3768h | 3768h | eUPHBOOK-Test | 21 | Comprion | Rel-8 | 40 | Xavier |  | 31.320 (external interface for communication with the ME) |  | CP-47 |  | PCG-24 |
| 7016 | 2211.2 | Deleted - Contact Manager API for Java™ Card test specification |  | 471d? | 2008-06-02 A | 2010-03-19 A | 100% | 2008-06-02 | 2010-03-19 | 471d? | finish no earlier than 2010-03-19 | C6 | 3768h | 3768h | eUPHBOOK-Test | 21 | Gemalto | Rel-8 | 40 | Xavier |  | 31.321 (internal interface (API)) |  | CP-47 |  | PCG-24 |
| 7017 | 2212 | Deleted - MS conformance testing of Support of Conversational Services in A/Gb mode via the PS domain |  | 401d? | 2008-02-25 A | 2009-09-04 A | 100% | 2008-02-25 | 2009-09-04 | 401d? | finish no earlier than 2009-09-04 | G3new | 3208h | 3208h | SCSAGBCT-MStest | 21 | Nokia | Rel-8 |  | Ingbert | SCSAGBCT-MStest | 51.010 |  | GP-43 |  | PCG-23 |
| 7018 | 2213 | Release 8 Studies | milestone | 0d? | 2005-10-07 A | 2005-10-07 A | 100% | 2005-10-07 | 2010-11-12 | 1332d? | start no earlier than 2000-01-03 | CP; GP; RP; SP |  |  |  |  |  | Rel-8 |  | All |  |  |  |  |  |  |
| 7019 | 2214 | Study on Customised Alerting Tone (CAT) Requirements |  | 245d? | 2005-10-07 A | 2006-09-14 A | 100% | 2005-10-07 | 2006-09-14 | 245d? | start no earlier than 2005-10-07 | S1 | 1960h | 1960h | FS_CAT |  | China Mobile | Rel-8 |  | Alain | FS_CAT | 22.982 |  |  |  |  |
| 7020 | 2215 | Study on Facilitating Machine to Machine Communication in GSM and UMTS (M2M) |  | 350d? | 2005-11-04 A | 2007-03-08 A | 100% | 2005-11-04 | 2007-03-08 | 350d? | finish no earlier than 2006-06-16 | S1 | 2800h | 2800h | FS_M2M |  | Siemens | Rel-8 |  | Alain | FS_M2M | 22.868 |  |  | MTC, M2M |  |
| 7021 | 2216 | Study on Network Composition |  | 526d? | 2005-12-07 A | 2007-12-12 A | 100% | 2005-12-07 | 2007-12-12 | 526d? | finish no earlier than 2006-09-27 | S1 | 4208h | 4208h | FS_NetComp |  | Nokia Siemens Networks | Rel-8 |  | Alain | FS_NetComp | 22.980 |  |  |  |  |
| 7022 | 2217 | Study on Requirements of IMS Multimedia Conferencing |  | 330d? | 2006-06-08 A | 2007-09-12 A | 100% | 2006-06-08 | 2007-09-12 | 330d? | finish no earlier than 2007-03-21 | S1 | 2640h | 2640h | FS_IMSconf |  | China Mobile | Rel-8 |  | Alain | FS_IMSconf | 22.948 |  |  |  |  |
| 7023 | 2218 | Study on support of a Public Warning System |  | 140d? | 2007-09-03 A | 2008-03-14 A | 100% | 2007-09-03 | 2008-03-14 | 140d? |  | S1 | 1120h | 1120h | FS_PWS |  | T-Mobile | Rel-8 |  | Alain | FS_PWS | 22.968 |  |  | Public Safety (I-A) |  |
| 7024 | 2219 | Study on Paging Permission with Access Control |  | 256d? | 2006-09-28 A | 2007-09-20 A | 100% | 2006-09-28 | 2007-09-20 | 256d? | finish no earlier than 2007-09-20 | S1 | 2048h | 2048h | FS_PPAC |  | NTT DoCoMo | Rel-8 |  | Alain | FS_PPAC | 22.908 |  |  |  |  |
| 7025 | 2220 | Study on Non-3GPP access Network Selection Principles (NSP) |  | 392d? | 2006-12-06 A | 2008-06-05 A | 100% | 2006-12-06 | 2008-06-05 | 392d? | finish no earlier than 2007-11-19 | S1 | 3136h | 3136h | FS_N3GtoNSP |  | Telefónica O2 | Rel-8 | 34 | Alain | FS_N3GtoNSP | 22.912 |  |  |  |  |
| 7026 | 2221 | Study on Value Added Services for Short Message Service |  | 263d? | 2006-12-06 A | 2007-12-07 A | 100% | 2006-12-06 | 2007-12-07 | 263d? | finish no earlier than 2007-12-07 | S1 | 2104h | 2104h | FS_VAS4SMS |  | China Mobile | Rel-8 | 34 | Alain | FS_VAS4SMS | 22.942 |  |  |  |  |
| 7027 | 2222 | Study on Service continuity between mobile and WLAN networks |  | 262d? | 2006-12-06 A | 2007-12-06 A | 100% | 2006-12-06 | 2007-12-06 | 262d? | finish no earlier than 2008-12-25 | S1 | 2096h | 2096h | FS_SMLSWLAN |  | NEC | Rel-8 | 34 | Alain | FS_SMLSWLAN | 22.937 |  |  | WLAN |  |
| 7028 | 2223 | Study on Services Alignment and Migration |  | 331d? | 2006-12-06 A | 2008-03-12 A | 100% | 2006-12-06 | 2008-03-12 | 331d? | finish no earlier than 2007-09-20 | S1 | 2648h | 2648h | FS_ServAl |  | Telefónica O2 | Rel-8 | 37 | Alain | FS_ServAl | 22.983 |  |  |  |  |

Notes:
- 6992: CP#42 completed. Updated WID CP-080278=>CP-080722 / WI rapporteur e-mail: philip.hodges@ericsson.com
- 6993: CP#42 completed. Updated WID CP-080278=>CP-080722 / WI rapporteur e-mail: philip.hodges@ericsson.com
- 6994: CP#42 completed. Updated WID CP-080278=>CP-080722 / WI rapporteur e-mail: philip.hodges@ericsson.com
- 6995: CP#42 completed. Updated WID CP-080278=>CP-080722 / WI rapporteur e-mail: philip.hodges@ericsson.com
- 6996: GP#39 completed / WI rapporteur e-mail: thomas.bitzer@alcatel-lucent.de
- 6997: GP#40 completed / WI rapporteur e-mail: Mungal Dhanda
- 6998: SP#42 completed by 22.071 CR0077
- 6999: GP#40 completed / WI rapporteur e-mail: Mungal Dhanda
- 7000: RP#42 WI closed at 95%. Considers Rel-9 performance requirements / WI rapporteur e-mail: Etienne Chaponniere (echaponn@qualcomm.com)
- 7001: GP#45 completed / WI rapporteur e-mail: mats.y.samuelsson@ericsson.com, hakan.e.grunditz@ericsson.com
- 7002: GP#45 completed / WI rapporteur e-mail: hakan.e.grunditz@ericsson.com
- 7003: GP#41 completed / WI rapporteur e-mail: mats.y.samuelsson@ericsson.com
- 7004: GP#40 completed / WI rapporteur e-mail: Franz.Segerer@ROHDE-SCHWARZ.COM
- 7005: SP#42 completed
- 7006: CP#57 completed / WI rapporteur e-mail: christer.holmberg@ericsson.com
- 7007: -
- 7008: SP#38 stopped. 25/07/08 Moved UID_31059 Study on All-IP Network (FS_AIPN/was AIPFS) to Rel-7 out of the stopped Rel-8 Feature UID_31067 Deleted - All-IP Network (AIPN) / WI rapporteur e-mail: c.masyu@nttdocomo.co.jp
- 7009: 22.258 withdrawn, superseded by 22.278 (UID 320022). SP#38 stopped / WI rapporteur e-mail: c.masyu@nttdocomo.co.jp
- 7010: SP#35 stopped / WI rapporteur e-mail: dhshim@lge.com
- 7011: SP#38 stopped
- 7012: SP#38 stopped (no support) / WI rapporteur e-mail: andre.jarvis@three.co.uk
- 7013: SP#38 stopped
- 7014: CP#47 work stopped/abandoned / WI rapporteur e-mail: Udo Willenbrink, Jacques Seif
- 7015: CP#47 work stopped/abandoned / WI rapporteur e-mail: Udo Willenbrink (uwillenbrink@comprion.com )
- 7016: CP#47 work stopped/abandoned / WI rapporteur e-mail: jacques.seif@gemalto.com
- 7017: GP#43 work stopped/abandoned (completion 0%) / WI rapporteur e-mail: arsi.heino@nokia.com
- 7018: -
- 7019: Spin-off Rel-8 Feature Customized Alerting Tone (CAT) Service UID_340029 / WI rapporteur e-mail: Qing Huang (huangqing@chinamobile.com)
- 7020: SP#35 completed. Spin-off SA3 Study on Security Aspects of Remote Provisioning and Change of Subscription for M2M (UID_370053). SP#40 Spin-off new Feature UID_410030 (NIMTC) / WI rapporteur e-mail: Juergen Merkel
- 7021: SP#38 completed / WI rapporteur e-mail: joerg.swetina@neclab.eu
- 7022: SP#37 completed. Spin-off New Feature UID_370026 Value-Added Services for Short Message Service (VAS4SMS) / WI rapporteur e-mail: Qing Huang (huangqing@chinamobile.com)
- 7023: SP#39 completed. Spin-off Rel-9 Feature UID_380057 (PWS) / WI rapporteur e-mail: mark.younge@t-mobile.com
- 7024: SP#37 completed. Spin-off new Feature UID_370084 (PPACR) / WI rapporteur e-mail: Katsuhiro NOGUCHI (noguchi@nttdocomo.co.jp)
- 7025: SP#38 completed. Spin-off New Feature UID_380062 (N3GTONSP). SP#40 WID updated SP-060930=>SP-080318. TR re-approved with new # 22.812=>22.912 / WI rapporteur e-mail: chris.friel@O2.com
- 7026: SP#38 completed. Spin-off New Feature UID_370026 (VAS4SM) / WI rapporteur e-mail: Qing Huang (huangqing@chinamobile.com)
- 7027: SP#38 completed / WI rapporteur e-mail: joerg.swetina@neclab.eu
- 7028: SP#39 completed. Spin-off Rel-9 Feature UID_330017 Services Alignment and Migration (ServAl) / WI rapporteur e-mail: chris.friel@O2.com

| ID | WBS | Task | Duration | Start | Finish | Complete | Baseline start | Baseline finish | Baseline duration | Constraint | Resources | Work | Actual work | Acronym | WI rapporteur name | WI rapporteur e-mail | Release | MCC resp | Acronym_3GU_Export | Impacted TSs and TRs | PCG approved | TSG approved | Special Focus Doc | Status Report | PCG stopped | TSG stopped |
| --- | --- | --- | --- | --- | --- | --- | --- | --- | --- | --- | --- | --- | --- | --- | --- | --- | --- | --- | --- | --- | --- | --- | --- | --- | --- | --- |
| 7029 | 2224 | **Study on 3GPP System Architecture Evolution** | 1115d? | 2004-12-03 A | 2009-03-12 A | 100% | 2004-12-03 | 2009-03-12 | 1115d? |  | S2; S3 | 34064h | 34064h | FS_SAE | Vodafone | chris.pudney@vodafone.com | Rel-8 | Maurice | FS_SAE |  |  |  |  |  |  |  |
| 7030 | 2224.1 | Stage 2 Interim conclusion for RAN Work to start | 990d? | 2004-12-03 A | 2008-09-18 A | 100% | 2004-12-03 | 2008-09-18 | 990d? | finish no earlier than 2005-09-23 | S2 | 7920h | 7920h | FS_SAE | Vodafone | chris.pudney@vodafone.com | Rel-8 | Maurice |  | 23.882 |  |  |  |  |  |  |
| 7031 | 2224.2 | Stage 2 study on 3GPP architectural development | 704d? | 2006-01-09 A | 2008-09-18 A | 100% | 2006-01-09 | 2008-09-18 | 704d? | finish no earlier than 2007-09-28 | S2 | 5632h | 5632h | FS_SAE | Vodafone | chris.pudney@vodafone.com | Rel-8 | Maurice |  | 23.882 |  |  |  |  |  |  |
| 7032 | 2224.3 | Security study for Inter-access mobility between non-3GPP and 3GPP system | 334d? | 2007-09-03 A | 2009-03-12 A | 100% | 2007-09-03 | 2009-03-12 | 334d? | finish no earlier than 2009-03-12 | S3 | 2672h | 2672h | FS_SAE | Nokia | dajiang.zhang@nokia.com | Rel-8 | Mirko |  | 33.821; 33.822 |  |  |  |  |  |  |
| 7033 | 2225 | Study on Stage 2 aspects of IMS Service Brokering | 589d? | 2006-06-19 A | 2008-09-18 A | 100% | 2006-06-19 | 2008-09-18 | 589d? | finish no earlier than 2008-09-18 | S2 | 4712h | 4712h | FS_ISB_ST2 | Telcordia | raquel@research.telcordia.com | Rel-8 | Maurice | FS_ISB_ST2 | 23.810 |  |  |  |  |  |  |
| 7034 | 2226 | Study on IMS utilizing multicast bearer services | 447d? | 2006-03-22 A | 2007-12-06 A | 100% | 2006-03-22 | 2007-12-06 | 447d? | finish no earlier than 2007-12-03 | S2 | 3576h | 3576h | FS_MLTICAST-IMS | Nokia Siemens Networks |  | Rel-8 | Maurice | FS_MLTICAST-IMS | 23.847 |  |  |  |  |  |  |
| 7035 | 2227 | Study on Multimedia Session Continuity | 291d? | 2007-04-26 A | 2008-06-05 A | 100% | 2007-04-26 | 2008-06-05 | 291d? | finish no earlier than 2008-06-05 | S2 | 2328h | 2328h | FS_MMSC | LG Electronics |  | Rel-8 | Maurice | FS_MMSC | 23.893 |  |  |  |  |  |  |
| 7036 | 2228 | **Study on centralized IMS service control** | 363d? | 2006-10-23 A | 2008-03-12 A | 100% | 2006-10-23 | 2008-03-12 | 363d? |  | S2; S1 | 10856h | 10856h | FS_ICS | Ericsson | peter.bleckert@ericsson.com | Rel-8 | Alain | FS_ICS |  | 21 | 38 |  |  |  |  |
| 7037 | 2228.1 | Study on centralized IMS services requirements | 268d? | 2007-03-05 A | 2008-03-12 A | 100% | 2007-03-05 | 2008-03-12 | 268d? | start no earlier than 2007-03-05 | S1 | 2144h | 2144h | FS_ICS-S1 | NEC | joerg.swetina@neclab.eu | Rel-8 | Alain | FS_ICS-S1 | 22.892 |  | 37 |  |  |  |  |
| 7038 | 2228.2 | Study on centralized IMS services control | 363d? | 2006-10-23 A | 2008-03-12 A | 100% | 2006-10-23 | 2008-03-12 | 363d? | finish no earlier than 2008-02-21 | S2 | 2904h | 2904h | FS_IMS_CSC | Alcatel-Lucent | andy.bennett@alcatel-lucent.com | Rel-8 | Maurice | FS_IMS_CSC | 23.892 |  |  |  |  |  |  |
| 7039 | 2229 | Study on Architecture of IMS based Customized Alerting Tone (CAT) | 208d? | 2007-12-04 A | 2008-09-18 A | 100% | 2007-12-04 | 2008-09-18 | 208d? | finish no earlier than 2008-09-08 | S2 | 1664h | 1664h | FS_CAT-St2 | China Mobile | WANG, Jing (wangjing@chinamobilecom) | Rel-8 | Maurice | FS_CAT-St2 | 23.872 | 21 | 38 |  |  |  |  |
| 7040 | 2230 | Study on Home (e)NodeB Security | 321d? | 2007-12-20 A | 2009-03-12 A | 100% | 2007-12-20 | 2009-03-12 | 321d? | finish no earlier than 2009-03-10 | S3 | 2568h | 2568h | FS_HNB_Sec | Huawei | yangyanmei@huawei.com | Rel-8 | Mirko | FS_HNB_Sec | 33.820 | 21 | 38 | HNB |  |  |  |
| 7041 | 2231 | Study on Transferring of emergency call data – in-band modem solution | 265d? | 2006-12-07 A | 2007-12-12 A | 100% | 2006-12-07 | 2007-12-12 | 265d? | finish no earlier than 2008-09-18 | S4 | 2120h | 2120h | eCALLIBMS | Airbiquity | lhong@airbiquity.com | Rel-8 | Paolo | eCALLIBMS | 26.967 |  |  | Public Safety (I-A) |  |  |  |
| 7042 | 2232 | Study on Element Operations Systems Function (EOSF) definition | 266d? | 2007-06-07 A | 2008-06-12 A | 100% | 2007-06-07 | 2008-06-12 | 266d? | finish no earlier than 2008-12-11 | S5 | 2128h | 2128h | OAM7-NIM-EOSF | China Mobile | Li Jian (lijian@chinamobile.com) | Rel-8 | Mirko | OAM7-NIM-EOSF | 32.819 |  |  |  |  |  |  |
| 7043 | 2233 | Study on SA5 MTOSI XML Harmonization | 351d? | 2006-05-10 A | 2007-09-12 A | 100% | 2006-05-10 | 2007-09-12 | 351d? | finish no earlier than 2007-12-14 | S5 | 2808h | 2808h | OAM8-NIM-XML | Nortel | jduguay@nortel.com | Rel-8 | Mirko | OAM8-NIM-XML | 32.818 |  |  |  |  |  |  |
| 7044 | 2234 | Study on Common Profile Storage (CPS) Framework of User Data for network services and management | 244d? | 2006-07-03 A | 2007-06-07 A | 100% | 2006-07-03 | 2007-06-07 | 244d? | finish no earlier than 2007-06-07 | S5 | 1952h | 1952h | OAM7-CPS | T-Mobile | istvan.aba@t-mobile.at | Rel-8 | Mirko | OAM7-CPS | 32.808 |  |  |  |  |  |  |
| 7045 | 2235 | Study on Management for LTE and SAE | 526d? | 2006-12-07 A | 2008-12-11 A | 100% | 2006-12-07 | 2008-12-11 | 526d? | finish no earlier than 2008-12-11 | S5 | 4208h | 4208h | FS_OAM_LTE_SAE | Ericsson | robert.petersen@ericsson.com | Rel-8 | Mirko | FS_OAM_LTE_SAE | 32.816 |  | 34 |  |  |  |  |
| 7046 | 2236 | Study on Charging Aspects of 3GPP System Evolution | 179d? | 2007-04-02 A | 2007-12-06 A | 100% | 2007-04-02 | 2007-12-06 | 179d? | finish no earlier than 2007-12-06 | S5 | 1432h | 1432h | FS_SAEcharg | Nokia Siemens Networks | Gerald.Goermer@nsn.com | Rel-8 | Mirko | FS_SAEcharg | 32.820 |  |  |  |  |  |  |
| 7047 | 2237 | Study on AS-MRFC media server control protocol | 583d? | 2006-03-22 A | 2008-06-13 A | 100% | 2006-03-22 | 2008-06-13 | 583d? | finish no earlier than 2008-06-13 | C1 | 4664h | 4664h | MRFC | Hewlett-Packard | mark.syrett@hp.com | Rel-8 | Frederic | MRFC | 24.880 |  |  |  |  |  |  |
| 7048 | 2238 | Study on IMS Restoration Procedures | 310d? | 2007-03-26 A | 2008-05-30 A | 100% | 2007-03-26 | 2008-05-30 | 310d? | finish no earlier than 2008-05-30 | C4 | 2480h | 2480h | FS_IMS_RP | Ericsson | german.blanco@ericsson.com | Rel-8 | Kimmo | FS_IMS_RP | 23.820 |  |  |  |  |  |  |
| 7049 | 2239 | Study on IMS Application Server Service Data Descriptions for AS interoperability | 261d? | 2007-09-14 A | 2008-09-12 A | 100% | 2007-09-14 | 2008-09-12 | 261d? | finish no earlier than 2008-09-12 | C4 | 2088h | 2088h | FS_IMS_ASIO | Alcatel-Lucent | Jean-Jacques Trottin | Rel-8 | Kimmo | FS_IMS_ASIO | 29.864 |  |  |  |  |  |  |
| 7050 | 2240 | Study on Customized Alerting Tone (CAT) solution for voice and video call in CS domain | 261d? | 2007-09-14 A | 2008-09-12 A | 100% | 2007-09-14 | 2008-09-12 | 261d? |  | C4 | 626.4h | 626.4h | FS_CAT_VVC_CS | China Mobile | zhanghao@chinamobile.com | Rel-8 | Kimmo | FS_CAT_VVC_CS | 29.882 |  |  |  |  |  |  |
| 7051 | 2241 | Study on InterWorking Function between MAP based and Diameter based interfaces | 266d? | 2007-11-30 A | 2008-12-05 A | 100% | 2007-11-30 | 2008-12-05 | 266d? | finish no earlier than 2008-12-05 | C4 | 2128h | 2128h | FS_MAP2Diam | Huawei | liming49985@huawei.com | Rel-8 | Kimmo | FS_MAP2Diam | 29.805 | 21 | 38 |  |  |  |  |
| 7052 | 2242 | Study on Scope of future HSPA Evolution for 1.28 Mcps TDD | 186d? | 2007-09-14 A | 2008-05-30 A | 100% | 2007-09-14 | 2008-05-30 | 186d? | finish no earlier than 2008-05-30 | R1 | 1488h | 1488h | FS_RAN-LCRTDDHSPAEvo | RITT | Xu Fei | Rel-8 | Patrick | FS_RAN-LCRTDDHSPAEvo | 25.824 |  | 37 |  | RP-080290 |  |  |
| 7053 | 2243 | Study on Synchronized E-DCH for UTRA FDD | 126d? | 2007-09-14 A | 2008-03-07 A | 100% | 2007-09-14 | 2008-03-07 | 126d? | finish no earlier than 2008-03-14 | R1 | 1008h | 1008h | FS_RAN-UplinkSync | Nokia Siemens Networks | Karri.Ranta-aho@nsn.com | Rel-8 | Patrick | FS_RAN-UplinkSync | 25.823 |  | 37 |  | RP-080068 |  |  |
| 7054 | 2244 | Study on Improved network controlled mobility between LTE and 3GPP2/mobile WiMAX radio technologies | 131d? | 2007-06-04 A | 2007-12-03 A | 100% | 2007-06-04 | 2007-12-03 | 131d? | finish no earlier than 2007-12-03 | R4 | 1048h | 1048h | FS_RAN-LTEmob | Motorola | hao.bi@Motorola.com | Rel-8 | Issam | FS_RAN-LTEmob | 36.938 |  |  |  | RP-070827 |  |  |
| 7055 | 2245 | Study on 3G Home NodeB/eNodeB | 325d? | 2007-03-05 A | 2008-05-30 A | 100% | 2007-03-05 | 2008-05-30 | 325d? | finish no earlier than 2008-05-30 | R4 | 2600h | 2600h | FS_RAN-HNBeNB | Motorola | howard.thomas@motorola.com | Rel-8 | Issam | FS_RAN-HNBeNB | 25.820 |  |  | HNB | RP-080289 |  |  |
| 7056 | 2246 | Study on A-interface over IP | 126d? | 2007-08-31 A | 2008-02-22 A | 100% | 2007-08-31 | 2008-02-22 | 126d? | finish no earlier than 2008-02-22 | GP | 1008h | 1008h | AINTIP | China Mobile, Ericsson | paul.schliwa-bertling@ericsson.com | Rel-8 | Paolo | AINTIP | 43.903 |  |  |  |  |  |  |
| 7057 | 2247 | Study on Multi-User Reusing-One-Slot | 782d? | 2007-11-16 A | 2010-11-12 A | 100% | 2007-11-16 | 2010-11-12 | 782d? | finish no earlier than 2010-11-12 | GP | 6248h | 6248h | MUROS | Nokia Siemens Networks | juergen.hofmann@nsn.com | Rel-8 | Paolo | MUROS | 45.914 |  |  |  |  |  |  |
| 7058 | 2248 | Study on Optimized Transmit Pulse Shape for Downlink EGPRS2-B | 657d? | 2007-11-16 A | 2010-05-21 A | 100% | 2007-11-16 | 2010-05-21 | 657d? | finish no earlier than 2010-05-27 | G1 | 5248.44h | 5248.44h | WIDER | Research In Motion, Nokia Siemens Networks | jdwyer@RIM.COM and eddie.riddington@nsn.com | Rel-8 | Paolo | WIDER | 45.913 |  |  |  |  |  |  |
| 7059 | 2249 | Deleted - Study on Mobility between 3GPP-WLAN Interworking and 3GPP Systems | 393d? | 2007-03-20 A | 2008-09-18 A | 100% | 2007-03-20 | 2008-09-18 | 393d? | finish no earlier than 2008-09-18 | S2 | 3144h | 3144h | FS_SM3GWLAN | Orange |  | Rel-8 | Maurice | FS_SM3GWLAN | withdrawn 23.827 |  |  | WLAN |  | PCG-21 | SP-41 |
| 7060 | 2250 | Deleted - equals 340035 -FS on Service continuity between mobile and WLAN networks | 75d? | 2007-09-03 A | 2007-12-14 A | 100% | 2007-09-03 | 2007-12-14 | 75d? | finish no earlier than 2007-12-14 | S1 | 600h | 600h | FSSCMobToW | BT | mike.meyerstein@bt.com | Rel-8 | Alain | FSSCMobToW | 22.937 |  | 37 |  |  | PCG-21 | SP-39 |
| 7061 | 2251 | Deleted - Study on Evaluation of LCS Control Plane Solution for EPS | 100d? | 2008-01-14 A | 2008-05-30 A | 100% | 2008-01-14 | 2008-05-30 | 100d? | finish no earlier than 2009-03-20 | S2 | 800h | 800h | FS_LCS_EPS | SiRF |  | Rel-8 | Maurice | FS_LCS_EPS | 23.891 |  | 38 |  |  | PCG-21 | SP-40 |
| 7062 | 2252 | Deleted - Study on HS-PDSCH serving cell change enhancements | 60d? | 2007-12-17 A | 2008-03-07 A | 100% | 2007-12-17 | 2008-03-07 | 60d? | finish no earlier than 2008-06-12 | R4 | 480h | 480h | FS_RAN-HSPDSCH | Qualcomm |  | Rel-8 | Issam | FS_RAN-HSPDSCH | none | 21 | 38 |  | RP-080070 | PCG-21 | RP-39 |
| 7063 | 2253 | Deleted - Study on Dual-Cell HSDPA operation | 261d? | 2007-08-15 A | 2009-03-06 A | 100% | 2007-08-15 | 2009-03-06 | 261d? | finish no earlier than 2009-03-06 | R1 | 2088h | 2088h | FS_RAN-DCHS | Qualcomm | Josef Blanz | Rel-8 | Patrick | FS_RAN-DCHS | withdrawn 25.825 v100 | 21 | 39 |  | RP-090066 | PCG-22 | RP-43 |
| 7064 | 2254 | --- RELEASE 7 --- | 679d? | 2005-05-02 A | 2007-12-06 A | 100% | 2005-05-02 | 2007-12-06 | 679d? | start no earlier than 2000-01-01 | CP; GP; RP; SP | 21728h | 21728h |  |  |  | Rel-7 | All |  |  |  |  |  |  |  |  |

Notes:
- 7029: SP#43 completed
- 7030: SP#41 completed
- 7031: SP#41 completed
- 7032: SP#43 completed
- 7033: SP#41 completed. No spin-off activity proposed. [Note: IMS Service Brokering enhancements UID_31088 moved back from R8 to R7 to give a home to 22228CR0036_(Rel-7)_S1-051232. Hence, Rel-7 ISB has Stage 1 only (and is misaligned with Rel-7 Stages 2/3.]
- 7034: SP#38 completed
- 7035: SP#40 completed
- 7036: SP#39 completed
- 7037: SP#39 completed
- 7038: SP#39 completed
- 7039: SP#41 completed as Rel-8
- 7040: SP#43 completed. Linked to RAN4 Study on 3G Home NodeB/eNodeB (UID_350039) and to SA5 Study on Self-Organizing Networks (SON) related OAM interfaces for Home NodeB (UID_360007)
- 7041: SP#38 completed. Spin-off WID UID_34042 (eCall_Phase2)
- 7042: SP#40 completed. WID updated SP-050608=>SP-070307
- 7043: SP#37 completed. WID updated SP-050295=>SP-070305
- 7044: SP#36 completed. Spin-off New Feature UID_400034 User Data Convergence (UDC)
- 7045: SP#42 completed
- 7046: SP#38 completed
- 7047: CP#40 completed. Spin-off New Feature UID_380035 (MRFC_TS)
- 7048: CP#40 completed. Spin-off WID UID_400012 (IMS_RP)
- 7049: CP#41 completed. Linked to SA5 Study on Common Profile Storage framework UID_320006. Spin-off WID UID_410003 (IMS_ASIO)
- 7050: CP#41 completed. Spin-off WID under Feature CAT UID_340029
- 7051: CP#42 completed. Spin-off implementation Building Block UID_410007 (MAP2Diam) under the SAES Feature UID_320005
- 7052: RP#40 completed
- 7053: RP#39 completed
- 7054: RP#38 completed
- 7055: RP#40 completed
- 7056: GP#37 completed. Spin-off implementation Feature AoIP (A-interface over IP) UID_50591
- 7057: GP#48 completed as Rel-8. Spin-off implementation WI UID_420002 VAMOS (Voice services over Adaptive Multi-user channels on One Slot)
- 7058: GP#46 completed
- 7059: SP#41 stopped. Draft TR 23.827 content implemented in TS 23.327.
- 7060: SP#39 stopped
- 7061: SP#40 spin-off Feature UID_400038 (LCS_CPS_EPS). SP#40 FS stopped
- 7062: RP#39 stopped (no TR produced). Spin-off HS-DSCH Serving Cell Change Enhancements (UID_39003)
- 7063: RP#43 stopped (draft TR 25.825 v100 withdrawn). Conclusions in RP-090318 (RAN1 findings of the UTRA Multi-Carrier Evolution study). RP#42 New WI approved on Dual-Cell HSDPA operation on adjacent carriers (UID_400052)
- 7064: -

| ID | WBS | Task | Type | Duration | Start | Finish | Complete | Baseline start | Baseline finish | Baseline duration | Constraint | Resources | Work | Actual work | Acronym | WI rapporteur name | WI rapporteur e-mail | Release | MCC resp | Acronym_3GU_Export | TSG stopped | PCG approved | TSG approved | Status Report | Special Focus Doc |
| --- | --- | --- | --- | --- | --- | --- | --- | --- | --- | --- | --- | --- | --- | --- | --- | --- | --- | --- | --- | --- | --- | --- | --- | --- | --- |
| 7065 | 2255 | **Identification of Communication Services in IMS** |  | 620d? | 2005-05-02 A | 2007-09-14 A | 100% | 2005-05-02 | 2007-09-14 | 620d? |  | S2; S1; C1; S5 | 29048h | 29048h | ServID | Ericsson | stephen.terrill@ericsson.com | Rel-7 | Maurice | ServID |  |  |  |  |  |
| 7066 | 2255.1 | TR on ServID |  | 232d? | 2005-05-02 A | 2006-03-21 A | 100% | 2005-05-02 | 2006-03-21 | 232d? | finish no earlier than 2006-03-20 | S2 | 1856h | 1856h | ServID | Ericsson | stephen.terrill@ericsson.com | Rel-7 | Maurice |  |  |  |  |  |  |
| 7067 | 2255.2 | Stage 1,2 of ServID |  | 144d? | 2005-11-11 A | 2006-05-31 A | 100% | 2005-11-11 | 2006-05-31 | 144d? | start no earlier than 2005-11-11 | S1; S2 | 2304h | 2304h | ServID | Ericsson | stephen.terrill@ericsson.com | Rel-7 | Maurice |  |  |  |  |  |  |
| 7068 | 2255.3 | Stage 3 of ServID |  | 250d? | 2006-03-31 A | 2007-03-15 A | 100% | 2006-03-31 | 2007-03-15 | 250d? | finish no earlier than 2007-03-15 | C1 | 2000h | 2000h | ServID | Ericsson | christer.holmberg@ericsson.com | Rel-7 | Frederic |  |  |  |  |  |  |
| 7069 | 2255.4 | Charging of ServID |  | 381d? | 2006-03-31 A | 2007-09-14 A | 100% | 2006-03-31 | 2007-09-14 | 381d? | finish no earlier than 2007-09-14 | S5 | 3048h | 3048h | ServID | Orange | alain.bibas@orange-ft.com | Rel-7 | Mirko |  |  |  |  |  |  |
| 7070 | 2256 | **Supporting Globally Routable User Agent URIs in IMS** |  | 415d? | 2005-11-14 A | 2007-06-15 A | 100% | 2005-11-14 | 2007-06-15 | 415d? |  | S2; S1; C1 | 14920h | 14920h | GRUU | Research In Motion | Adrian Buckley (abuckley@rim.com) | Rel-7 | Maurice | GRUU |  |  |  |  |  |
| 7071 | 2256.1 | Deleted - TR on GRUU |  | 219d? | 2005-11-14 A | 2006-09-14 A | 100% | 2005-11-14 | 2006-09-14 | 219d? | finish no earlier than 2006-09-14 | S2 | 1752h | 1752h | GRUU | Research In Motion | Adrian Buckley (abuckley@rim.com) | Rel-7 | Maurice |  | SP-32 |  |  |  |  |
| 7072 | 2256.2 | Stage 1,2 of GRUU |  | 65d? | 2006-07-03 A | 2006-09-29 A | 100% | 2006-07-03 | 2006-09-29 | 65d? | start no earlier than 2006-07-03 | S1; S2 | 1040h | 1040h | GRUU | Research In Motion | Adrian Buckley (abuckley@rim.com) | Rel-7 | Maurice |  |  |  |  |  |  |
| 7073 | 2256.3 | Stage 3 of GRUU |  | 271d? | 2006-06-02 A | 2007-06-15 A | 100% | 2006-06-02 | 2007-06-15 | 271d? | finish no earlier than 2007-06-15 | C1 | 2168h | 2168h | GRUU | CableLabs | Bernie McKibben (b.mckibben@cablelabs.com) | Rel-7 | Frederic |  |  |  |  |  |  |
| 7074 | 2257 | **Multimedia Telephony Service for IMS** |  | 2919d? | 2006-02-01 A | 2017-03-15 A | 100% | 2006-02-01 | 2007-06-15 | 357d? |  | S1; C1; S4 | 81952h | 81952h | MTSI | Ericsson | peter.bleckert@ericsson.com | Rel-7 | Alain | MTSI |  | 35 | 69 |  |  |
| 7075 | 2257.1 | Stage 1 of MTSI |  | 173d? | 2006-02-01 A | 2006-09-29 A | 100% | 2006-02-01 | 2006-09-29 | 173d? | start no earlier than 2006-02-01 | S1 | 1384h | 1384h | MTSI-REQ | Ericsson | peter.bleckert@ericsson.com | Rel-7 | Alain | MTSI-REQ |  |  |  |  |  |
| 7076 | 2257.2 | Stage 3 of MTSI |  | 330d? | 2006-03-10 A | 2007-06-14 A | 100% | 2006-03-10 | 2007-06-14 | 330d? | finish no earlier than 2007-06-15 | C1 | 2640h | 2640h | MTSI | Ericsson | christer.holmberg@ericsson.com | Rel-7 | Frederic | MTSI |  |  |  |  |  |
| 7077 | 2257.3 | Media handling and interaction in MTSI |  | 262d? | 2006-03-15 A | 2007-03-15 A | 100% | 2006-03-15 | 2007-03-15 | 262d? | finish no earlier than 2007-03-15 | S4 | 2096h | 2096h | MTSI-MHI | Ericsson | olle.franceschi@ericsson.com | Rel-7 | Paolo | MTSI-MHI |  |  |  |  |  |
| 7078 | 2257.4 | UE Conformance Test Aspects - Multimedia Telephony Services for IMS (MTSI) over fixed access |  | 393d? | 2015-09-15 A | 2017-03-15 A | 100% |  |  |  | finish no earlier than 2017-03-15 | R5 | 3144h | 3144h | MTSI_FIXED_ACCESS-UEConTest | Telecom Italia |  | Rel-7 |  |  |  | 35 | 69 |  |  |
| 7079 | 2257.5 | UE Conformance Test Aspects – Multimedia Telephony Services for IMS (MTSI) over WLAN |  | 329d? | 2015-09-15 A | 2016-12-15 A | 100% |  |  |  | finish no earlier than 2016-12-15 | R5 | 2632h | 2632h | MTSI_WLAN-UEConTest | Ericsson |  | Rel-7 |  |  |  | 35 | 69 |  |  |
| 7080 | 2257.6 | Deleted - duplicates UID7039 - IMS Multimedia Telephony Service | milestone | 0d? | 2007-06-15 A | 2007-06-15 A | 100% | 2007-06-15 | 2007-06-15 | 0d? | start no earlier than 2007-06-15 | S1 |  |  | MMTEL | Ericsson | peter.bleckert@ericsson.com | Rel-7 | Alain | MMTEL | SP-32 |  |  |  |  |
| 7081 | 2258 | Multimedia Telephony Service for IMS (MTSI) - UE Conformance Testing |  | 387d | 2007-09-19 A | 2009-03-12 A | 100% | 2007-09-19 | 2009-03-12 | 387d | finish no earlier than 2009-03-13 | R5 | 1664h | 1664h | MTSI-UEConTest | Ericsson, Motorola | Leif.Mattisson@ericsson.com, Jacob.John@motorola.com | Rel-7 | Ingbert | MTSI-UEConTest |  |  |  | RP-090056 |  |
| 7082 | 2259 | TISPAN requirements for Multimedia Telephony with PSTN/ISDN simulation services |  | 58d? | 2007-09-18 A | 2007-12-06 A | 100% | 2007-09-18 | 2007-12-06 | 58d? | start no earlier than 2007-09-18 | S1 | 464h | 464h | TMMTEL7 |  |  | Rel-7 | Alain | TMMTEL7 |  |  | 37 |  |  |
| 7083 | 2260 | **Maintenance of TISPAN release 1 common IMS** |  | 180d? | 2007-07-02 A | 2008-03-07 A | 100% | 2007-07-02 | 2008-03-07 | 180d? |  | S2 | 5808h | 5808h | MCIMSTR1 | Ericsson | Raymond Forbes | Rel-7 | Maurice | MCIMSTR1 |  | 21 | 38 |  |  |
| 7084 | 2260.1 | SA1 aspects of MCIMSTR1 |  | 58d? | 2007-09-18 A | 2007-12-06 A | 100% | 2007-09-18 | 2007-12-06 | 58d? | finish no earlier than 2007-12-06 | S1 | 464h | 464h | MCIMSTR1-S1 | Telecom Italia | Marco.DeLuca1@telecomitalia.it | Rel-7 | Alain | MCIMSTR1-S1 |  | 21 | 38 |  |  |
| 7085 | 2260.2 | SA2 aspects of MCIMSTR1 |  | 58d? | 2007-09-18 A | 2007-12-06 A | 100% | 2007-09-18 | 2007-12-06 | 58d? | finish no earlier than 2007-12-06 | S2 | 464h | 464h | MCIMSTR1-S2 | Ericsson | Raymond Forbes | Rel-7 | Maurice | MCIMSTR1-S2 |  | 21 | 38 |  |  |
| 7086 | 2260.3 | SA1,SA2 part of Maintenance of TISPAN release 1 common IMS |  | 114d? | 2007-07-02 A | 2007-12-06 A | 100% | 2007-07-02 | 2007-12-06 | 114d? | finish no earlier than 2007-12-06 | S2; S1 | 1824h | 1824h | IMS_Comm_Mtce7 | BT, Ericsson | Dick Knight, Raymond Forbes | Rel-7 | Maurice | IMS_Comm_Mtce7 |  | 21 | 38 |  |  |
| 7087 | 2260.4 | Maintenance of TISPAN R1 |  | 86d? | 2007-11-09 A | 2008-03-07 A | 100% | 2007-11-09 | 2008-03-07 | 86d? | start no earlier than 2007-11-09 | C1; C3; C4 | 2064h | 2064h | MAINT_R1 | Alcatel-Lucent | Keith Drage (drage@alcatel-lucent.com) | Rel-7 | Frederic | MAINT_R1 |  | 21 | 38 |  |  |
| 7088 | 2261 | **PS domain and IMS impacts for supporting IMS Emergency calls (EMC1)** |  | 2934d? | 2000-09-18 A | 2011-12-09 A | 100% | 2000-09-18 | 2011-12-09 | 2934d? |  | S2; S1; C1; C4; IETF | 185422h | 185422h | EMC1 | Siemens | Rainer Liebhart | Rel-7 | Maurice | EMC1 |  |  |  |  | Public Safety (I-A) |
| 7089 | 10.1.1 | Service Requirements for IP-based emergency calls |  | 985d | 2000-09-18 A | 2004-06-25 A | 100% | 2000-09-18 | 2004-06-25 | 985d | finish no earlier than 2004-06-25 | S1 | 7880h | 7880h | EMC1 | Siemens | Rainer Liebhart | Rel-7 | Alain |  |  |  |  |  | Public Safety (I-A) |
| 7090 | 2261.2 | Study on Stage 2 for IMS-level solution |  | 668d? | 2003-02-26 A | 2005-09-16 A | 100% | 2003-02-26 | 2005-09-16 | 668d? | finish no earlier than 2005-09-16 | S2 | 5344h | 5344h | EMC1 | Siemens | Rainer Liebhart | Rel-7 | Maurice |  |  |  |  |  | Public Safety (I-A) |
| 7091 | 2261.3 | Study on Stage 2 for GPRS-level solution |  | 301d? | 2004-10-14 A | 2005-12-08 A | 100% | 2004-10-14 | 2005-12-08 | 301d? | finish no earlier than 2005-12-08 | S2 | 2408h | 2408h | EMC1 | Siemens | Rainer Liebhart | Rel-7 | Maurice |  |  |  |  |  | Public Safety (I-A) |
| 7092 | 2261.4 | Stage 2 Specification Phase - IMS-level |  | 200d? | 2005-09-05 A | 2006-06-09 A | 100% | 2005-09-05 | 2006-06-09 | 200d? | finish no earlier than 2006-06-09 | S2 | 1600h | 1600h | EMC1 | Siemens | Rainer Liebhart | Rel-7 | Maurice |  |  |  |  |  | Public Safety (I-A) |
| 7093 | 2261.5 | Deleted - Stage 2 Specification Phase - GPRS-level | milestone | 0d? | 2007-03-02 A | 2007-03-02 A | 100% | 2007-03-02 | 2007-03-02 | 0d? | start no earlier than 2007-03-02 | S2 |  |  | EMC1 | Siemens | Rainer Liebhart | Rel-7 | Maurice |  | SP-32 |  |  |  | Public Safety (I-A) |

Notes:
- 7065: WID approved SP#28. WID updated SP#32
- 7066: - / Impacted TSs and TRs: 23.816
- 7067: - / Impacted TSs and TRs: 22.228; 23.228; 23.203
- 7068: CP#32 approved WID / Impacted TSs and TRs: 23.218; 24.229
- 7069: - / Impacted TSs and TRs: 32.260; 32.298; 32.299
- 7070: SP#29 approved WID
- 7071: Abandoned
- 7072: SP#29 approved WID / Impacted TSs and TRs: 22.228; 23.228; 23.218; 24.229
- 7073: CP#32 approved WID / Impacted TSs and TRs: 24.229
- 7074: -
- 7075: - / Impacted TSs and TRs: 22.173
- 7076: - / Impacted TSs and TRs: 24.173
- 7077: - / Impacted TSs and TRs: 26.114
- 7078: tested: REL-7 SA/CT WI MTSI;1/1/16: Compl:0%->5%¦22/3/16: Compl:5%->15%1/7/16: Compl:15%->30% ¦21
- 7079: tested: REL-7 WI MTSI¦1/1/16: Compl:0%->5%1/1/16: WID: RP-151334->RP-15177022/3/16: Compl:5%->10%
- 7080: - / Impacted TSs and TRs: 22.173
- 7081: RP#43 completed. Linked UID_7038 (MTSI) / Impacted TSs and TRs: 34.123-1; 34.123-2; 34.123-3; 34.229-1; 34.229-2
- 7082: - / Impacted TSs and TRs: 22.273 (EI 181 002 maintenance)
- 7083: - / Impacted TSs and TRs: http://www.3gpp.org/specs/TISPAN-IMS-ansfer.htm
- 7084: - / Impacted TSs and TRs: 22.173; 22.273
- 7085: - / Impacted TSs and TRs: 23.406; 23.417; 23.508.23.509; 23.511
- 7086: SP#38 completed / Impacted TSs and TRs: 22.173; 22.273; 22.401; 23.406; 23.417; 23.508; 23.509; 23.511
- 7087: CP#39 completed / Impacted TSs and TRs: 24.404; 24.405; 24.406; 24.407; 24.408; 24.410; 24.411; 24.416; 29.421; 24.423; 24.428; 24.429; 29.433; 24.441; 24.403; 29.427; 24.430; 29.412
- 7088: - / Impacted TSs and TRs: EMC1
- 7089: - / Impacted TSs and TRs: 22.101
- 7090: - / Impacted TSs and TRs: 23.867
- 7091: - / Impacted TSs and TRs: 23.867
- 7092: - / Impacted TSs and TRs: 23.060; 23.167; 23.203; 23.221; 23.228; 23.234; 23.271; 23.406
- 7093: -

| ID | WBS | Task | Type | Duration | Start | Finish | Complete | Baseline start | Baseline finish | Baseline duration | Constraint | Resources | Work | Actual work | Acronym | WI rapporteur name | WI rapporteur e-mail | Release | MCC resp | Special Focus Doc | Impacted TSs and TRs | PCG approved | TSG approved | TSG stopped | Acronym_3GU_Export | Created at | Status Report |
| --- | --- | --- | --- | --- | --- | --- | --- | --- | --- | --- | --- | --- | --- | --- | --- | --- | --- | --- | --- | --- | --- | --- | --- | --- | --- | --- | --- |
| 7094 | 10.1 | **Emergency Call Enhancements for IP& PS Based Calls – stage 3** |  | 1549d? | 2006-01-09 A | 2011-12-09 A | 100% | 2006-01-09 | 2011-12-09 | 1549d? |  | C1; C4; IETF | 50829.8h | 50829.8h | EMC1 | Ericsson | alf.heidermark@ericsson.com | Rel-7 | Frederic | Public Safety (I-A) |  |  |  |  |  |  |  |
| 7095 | 10.1.2 | CT1 IMS aspects to support IMS Emergency sessions |  | 350.82d | 2006-01-09 A | 2007-06-15 A | 100% | 2006-01-09 | 2007-06-15 | 350.82d | finish no earlier than 2007-06-15 | C1 | 2806.56h | 2806.56h | EMC1 | Ericsson | alf.heidermark@ericsson.com | Rel-7 | Frederic | Public Safety (I-A) | 24.229 |  |  |  |  |  |  |
| 7096 | 2261.6.2 | (IETF) CT1 IMS aspects to support IMS Emergency sessions |  | 452d? | 2006-01-09 A | 2011-12-09 A | 100% | 2006-01-09 | 2011-12-09 | 452d? | finish no earlier than 2011-12-09 | C1-IETF | 3608h | 3608h | EMC1 | Keith Drage |  | Rel-7 | Frederic | Public Safety (I-A) | RFC 6442 (was draft-ietf-sipcore-location-conveyance) | 27 | 52 |  |  |  |  |
| 7097 | 10.1.2 | Deleted - CT3 IMS aspects to support IMS Emergency sessions |  | 95d | 2006-05-08 A | 2006-09-15 A | 100% | 2006-05-08 | 2006-09-15 | 95d | finish no earlier than 2006-09-15 | C3 | 760h | 760h | EMC1 | Ericsson | alf.heidermark@ericsson.com | Rel-7 | Adrian | Public Safety (I-A) | 29.163 |  |  | CP-33 |  |  |  |
| 7098 | 10.1.5 | Deleted - CT3 PS domain aspects to support IMS Emergency sessions |  | 95d | 2006-05-08 A | 2006-09-15 A | 100% | 2006-05-08 | 2006-09-15 | 95d | start no earlier than 2006-05-08 | C3 | 760h | 760h | EMC1 | Ericsson | alf.heidermark@ericsson.com | Rel-7 | Adrian | Public Safety (I-A) | 29.061 |  |  | CP-33 |  |  |  |
| 7099 | 10.1.5 | CT1 PS domain aspects to support IMS Emergency sessions |  | 349.9d | 2006-01-09 A | 2007-06-15 A | 100% | 2006-01-09 | 2007-06-15 | 349.9d | finish no earlier than 2007-06-15 | C1 | 2799.2h | 2799.2h | EMC1 | Ericsson | alf.heidermark@ericsson.com | Rel-7 | Frederic | Public Safety (I-A) | 24.008; 24.234 |  |  |  |  |  |  |
| 7100 | 10.1.5 | CT4 PS domain aspects to support IMS Emergency sessions |  | 365d | 2006-01-09 A | 2007-06-01 A | 100% | 2006-01-09 | 2007-06-01 | 365d | finish no earlier than 2007-06-01 | C4 | 2920h | 2920h | EMC1-GPRSc4 | Ericsson | alf.heidermark@ericsson.com | Rel-7 | Kimmo | Public Safety (I-A) | 29.060 |  |  |  | EMC1-GPRSc4 |  |  |
| 7101 | 2262 | IMS Support of Conferencing |  | 355d? | 2005-11-04 A | 2007-03-15 A | 100% | 2005-11-04 | 2007-03-15 | 355d? | finish no earlier than 2007-03-15 | C1 | 2840h | 2840h | IMSconf | Alcatel-Lucent | Keith Drage (drage@alcatel-lucent.com) | Rel-7 | Frederic |  | 24.147; 24.229 |  |  |  | IMSconf |  |  |
| 7102 | 2263 | Performance Characterization of VoIMS over HSDPA\EUL channels |  | 713d? | 2005-03-15 A | 2007-12-06 A | 100% | 2005-03-15 | 2007-12-06 | 713d? | finish no earlier than 2007-12-06 | S4 | 5704h | 5704h | VoIMS-PCVoIMS | Alcatel-Lucent | mcgowan@alcatel-lucent.com | Rel-7 | Paolo |  | 26.935 |  |  |  | VoIMS-PCVoIMS |  |  |
| 7103 | 2264 | **WLAN-UMTS Interworking Phase 2** |  | 371d? | 2004-01-05 A | 2005-06-07 A | 100% | 2004-01-05 | 2005-06-07 | 371d? |  | S1; S2 | 6856h | 6856h | WLAN2 | Telenor | frederic.paint@telenor.com | Rel-7 | Alain | WLAN | 33.234 (SP-36 SA3 CRs approved) |  |  |  | WLAN2, WLAN-SC |  |  |
| 7104 | 2264.1 | Stage 1 on Session Continuity |  | 115d? | 2004-01-05 A | 2004-06-11 A | 100% | 2004-01-05 | 2004-06-11 | 115d? | start no earlier than 2004-01-05 | S1 | 920h | 920h | WLAN2 |  |  | Rel-7 | Alain | WLAN | 22.234 |  |  |  |  | SP-24 |  |
| 7105 | 2264.2 | Stage 2 on Session Continuity: covered by SAE | milestone | 0d? | 2005-06-07 A | 2005-06-07 A | 100% | 2005-06-07 | 2005-06-07 | 0d? | finish no earlier than 2005-06-07 | S2 |  |  | WLAN2 |  |  | Rel-7 | Maurice | WLAN |  |  |  |  |  |  |  |
| 7106 | 2265 | **WLAN Interworking – Private Network access from WLAN 3GPP IP Access** |  | 252d? | 2005-10-10 A | 2006-09-26 A | 100% | 2005-10-10 | 2006-09-26 | 252d? |  | S2; C1; C3; C4 | 17704h | 17704h | WLANPNA | NEC | Toshiyuki Tamura (tamurato@aj.jp.nec.com) | Rel-7 | Maurice | WLAN |  |  |  |  | WLANPNA |  |  |
| 7107 | 2265.1 | WLAN-PNA - Stage 2 |  | 185d? | 2005-10-10 A | 2006-06-23 A | 100% | 2005-10-10 | 2006-06-23 | 185d? | start no earlier than 2005-10-10 | S2 | 1480h | 1480h | WLANPNA-st2 | NEC | Toshiyuki Tamura (tamurato@aj.jp.nec.com) | Rel-7 | Maurice | WLAN | 23.234; 33.234 |  |  |  | WLANPNA-st2 |  |  |
| 7108 | 2265.2 | **WLAN-PNA - Stage 3** |  | 170d? | 2006-02-01 A | 2006-09-26 A | 100% | 2006-02-01 | 2006-09-26 | 170d? |  | C1; C3; C4 | 8160h | 8160h | WLANPNA-st3 | NEC |  | Rel-7 | Frederic | WLAN |  |  |  |  | WLANPNA-st3 |  |  |
| 7109 | 2265.2.1 | CT1 aspets for WLAN-PNA |  | 170d? | 2006-02-01 A | 2006-09-26 A | 100% | 2006-02-01 | 2006-09-26 | 170d? | start no earlier than 2006-02-01 | C1 | 1360h | 1360h | WLANPNA-st3 | NEC |  | Rel-7 | Frederic | WLAN | 24.234 |  |  |  |  |  |  |
| 7110 | 2265.2.2 | CT3 aspets for WLAN-PNA |  | 170d? | 2006-02-01 A | 2006-09-26 A | 100% | 2006-02-01 | 2006-09-26 | 170d? | start no earlier than 2006-02-01 | C3 | 1360h | 1360h | WLANPNA-st3 | NEC |  | Rel-7 | Adrian | WLAN | 29.161 |  |  |  |  |  |  |
| 7111 | 2265.2.3 | Deleted - CT4 aspets for WLAN-PNA |  | 170d? | 2006-02-01 A | 2006-09-26 A | 100% | 2006-02-01 | 2006-09-26 | 170d? | start no earlier than 2006-02-01 | C4 | 1360h | 1360h | WLANPNA-st3 | NEC |  | Rel-7 | Kimmo | WLAN | 29.234 |  |  | CP-32 |  |  |  |
| 7112 | 2266 | **Enhancements to support QoS provisioning over 3GPP/WLAN Interworking** |  | 520d? | 2005-03-14 A | 2007-03-09 A | 100% | 2005-03-14 | 2007-03-09 | 520d? |  | S2; C4; C1 | 16680h | 16680h | WLANQOS | Samsung |  | Rel-7 | Maurice | WLAN |  |  |  |  | WLANQOS |  |  |
| 7113 | 2266.1 | Deleted - TR on support of QoS on WLAN |  | 232d? | 2005-03-14 A | 2006-01-31 A | 100% | 2005-03-14 | 2006-01-31 | 232d? | start no earlier than 2005-03-14 | S2 | 1856h | 1856h | WLANQOS | Samsung |  | Rel-7 | Maurice | WLAN | 23.836 |  |  | SP-32 |  |  |  |
| 7114 | 2266.2 | Stage 2 on support of QoS over 3GPP/WLAN interworking |  | 108d? | 2006-02-01 A | 2006-06-30 A | 100% | 2006-02-01 | 2006-06-30 | 108d? | start no earlier than 2006-02-01 | S2 | 864h | 864h | WLANQOS | Samsung |  | Rel-7 | Maurice | WLAN | 23.234 |  |  |  |  |  |  |
| 7115 | 2266.3 | Stage 3 CT4 on support of QoS over 3GPP/WLAN Interworking |  | 121d? | 2006-09-22 A | 2007-03-09 A | 100% | 2006-09-22 | 2007-03-09 | 121d? | finish no earlier than 2007-03-09 | C4 | 968h | 968h | WLANQOS | Huawei | zhang.peng@huawei.com | Rel-7 | Kimmo | WLAN | 29.234; 23.008 |  |  |  |  |  |  |
| 7116 | 2266.4 | Stage 3 CT1 on support of QoS over 3GPP/WLAN Interworking |  | 64d? | 2006-09-04 A | 2006-11-30 A | 100% | 2006-09-04 | 2006-11-30 | 64d? | finish no earlier than 2006-11-30 | C1 | 512h | 512h | WLANQOS | Huawei | zhang.peng@huawei.com | Rel-7 | Frederic | WLAN | 24.234 |  | 34 |  |  |  |  |
| 7117 | 2267 | **Location Services enhancements** |  | 906d? | 2004-06-28 A | 2007-12-17 A | 100% | 2004-06-28 | 2007-12-17 | 906d? |  | S1; S2; GP; C4; R2 | 81525.6h | 81525.6h | LCS3 |  |  | Rel-7 | Alain |  |  |  |  |  | LCS3 |  |  |
| 7118 | 2267.1 | Stage 2 for LCS3 (including IMS emergency location aspects) |  | 446d? | 2004-12-31 A | 2006-09-15 A | 100% | 2004-12-31 | 2006-09-15 | 446d? | finish no earlier than 2006-09-15 | S2 | 3568h | 3568h | LCS3 | SiRF | brodilitz@sirf.com | Rel-7 | Maurice |  | 23.271 |  |  |  |  |  |  |
| 7119 | 2267.2 | LCS Enhancements related to Location-Based Services |  | 695d? | 2005-01-03 A | 2007-08-31 A | 100% | 2005-01-03 | 2007-08-31 | 695d? | finish no earlier than 2007-08-31 | GP | 5560h | 5560h | LCS3-LBS | SiRF | kjudge@sirf.com | Rel-7 | Paolo |  | 43.059; 44.031; 48.008; 49.031 |  |  |  | LCS3-LBS |  |  |
| 7120 | 2267.3 | CT4 aspects for LCS UEPos-LBS |  | 240d? | 2006-01-02 A | 2006-12-01 A | 100% | 2006-01-02 | 2006-12-01 | 240d? | finish no earlier than 2006-12-01 | C4 | 1920h | 1920h | LCS3-UEPos-LBS | SiRF | brodilitz@sirf.com | Rel-7 | Kimmo |  | 24.030; 24.080; 29.002 |  |  |  | LCS3-UEPos-LBS |  |  |
| 7121 | 2267.4 | UE positioning - Velocity |  | 394d? | 2005-03-15 A | 2006-09-15 A | 100% | 2005-03-15 | 2006-09-15 | 394d? | finish no earlier than 2006-09-15 | R2 | 3152h | 3152h | LCS3-UEPos-Velocity | SiRF | BRodilitz@SiRF.com | Rel-7 | Yong-Jun |  | 25.305; 25.331; 25.410; 25.413; 25.453 |  |  |  | LCS3-UEPos-Velocity |  | RP-060459 |
| 7122 | 2267.5 | Inclusion of Uplink TDOA UE positioning method in the UTRAN specifications |  | 849d? | 2004-09-15 A | 2007-12-17 A | 100% | 2004-09-15 | 2007-12-17 | 849d? | finish no earlier than 2007-12-17 | R2 | 6792h | 6792h | LCS3-UEPos-UTDOA | TruePosition | Robert Gross (rgross@polariswireless.com) | Rel-7 | Yong-Jun |  | 25.305; 25.453; new 25.111 |  |  |  | LCS3-UEPos-UTDOA |  | RP-070797 |

Notes:
- 7094: -
- 7095: -
- 7096: CP#54 completed
- 7097: Cancelled for Rel-7 and there is no corresponding Rel-8 WI
- 7098: Cancelled for Rel-7 and there is no corresponding Rel-8 WI
- 7099: -
- 7100: -
- 7101: CP#35 revised WID
- 7102: -
- 7103: Created at SP#27 because of WLAN items belonging to Rel-7. Acronym changed from "WLAN2, WLAN-SC"
- 7104: Acronym changed from "WLAN2, WLAN-SC"
- 7105: Acronym changed from "WLAN2, WLAN-SC"
- 7106: -
- 7107: Approved at SP#29
- 7108: Approved at CP#29
- 7109: Approved at CP#29
- 7110: Approved at CP#29
- 7111: CT4#31¦no impacts identified, therefore completed. CP-32 stopped
- 7112: Moved from FS section Feb 06. SP-30 updated WID
- 7113: SP#32 stopped
- 7114: SP#30 updated WID
- 7115: CP#33 approved WID
- 7116: CP#33 approved WID
- 7117: -
- 7118: SP#27 approved WID
- 7119: -
- 7120: -
- 7121: -
- 7122: -

| ID | WBS | Task | Duration | Start | Finish | Complete | Baseline start | Baseline finish | Baseline duration | Constraint | Resources | Work | Actual work | Acronym | WI rapporteur name | WI rapporteur e-mail | Release | MCC resp | Special Focus Doc | Acronym_3GU_Export | TSG stopped | TSG approved | Status Report | PCG approved |
| --- | --- | --- | --- | --- | --- | --- | --- | --- | --- | --- | --- | --- | --- | --- | --- | --- | --- | --- | --- | --- | --- | --- | --- | --- |
| 7123 | 2267.6 | **LCS for 3GPP Interworking WLAN** | 700d? | 2004-06-28 A | 2007-03-02 A | 100% | 2004-06-28 | 2007-03-02 | 700d? |  | S1; S2 | 17501.6h | 17501.6h | LCS3-IWLAN | Telcordia | Mike Loushine | Rel-7 | Alain | WLAN | LCS3-IWLAN |  |  |  |  |
| 7124 | 2267.6.1 | FS on 3GPP system to WLAN Interworking with LCS | 512.7d? | 2004-06-28 A | 2006-06-30 A | 100% | 2004-06-28 | 2006-06-30 | 512.7d? | finish no earlier than 2005-09-29 | S1 | 4101.6h | 4101.6h | LCS3-IWLAN-FSs1 | Telcordia | Mike Loushine | Rel-7 | Alain |  | LCS3-IWLAN-FSs1 |  |  |  |  |
| 7125 | 2267.6.2 | Deleted - Study of work on an LCS architecture for I-WLAN. | 180d? | 2006-06-26 A | 2007-03-02 A | 100% | 2006-06-26 | 2007-03-02 | 180d? | finish no earlier than 2007-03-02 | S2 | 1440h | 1440h | LCS3-IWLAN-FSs2 | LG Electronics | dhshim@lge.com ; phede@lge.com | Rel-7 | Maurice |  | LCS3-IWLAN-FSs2 | SP-35 |  |  |  |
| 7126 | 2267.6.3 | Stage 2 for LCS architecture for I-WLAN | 95d? | 2006-10-23 A | 2007-03-02 A | 100% | 2006-10-23 | 2007-03-02 | 95d? | finish no earlier than 2007-03-02 | S2 | 760h | 760h | LCS3-IWLAN | LG Electronics | dhshim@lge.com ; phede@lge.com | Rel-7 | Maurice |  | LCS3-IWLAN |  | 34 |  |  |
| 7127 | 2267.7 | Deleted - UE positioning Rel-7 | 849d? | 2004-09-15 A | 2007-12-17 A | 100% | 2004-09-15 | 2007-12-17 | 849d? |  | RP | 6792h | 6792h | LCS3-UEpos |  |  | Rel-7 | Yong-Jun |  | LCS3-UEpos | RP-38 |  |  |  |
| 7128 | 2268 | **MBMS Enhancements** | 625d? | 2005-07-11 A | 2007-11-30 A | 100% | 2005-07-11 | 2007-11-30 | 625d? |  | S1; R1; C3 | 20844.6h | 20844.6h | MBMSE | China Mobile | liuhongyfw@chinamobile.com | Rel-7 | Alain |  | MBMSE |  |  |  |  |
| 7129 | 2268.1 | Stage 1 of MBMSE | 109d? | 2005-07-11 A | 2005-12-08 A | 100% | 2005-07-11 | 2005-12-08 | 109d? | finish no earlier than 2005-12-08 | S1 | 872h | 872h | MBMSE | China Mobile | liuhongyfw@chinamobile.com | Rel-7 | Alain |  |  |  | 34 |  |  |
| 7130 | 2268.2 | MBMS FDD Physical layer Enhancements | 117.29d? | 2006-12-15 A | 2007-06-04 A | 100% | 2006-12-15 | 2007-06-04 | 117.29d? | finish no earlier than 2007-06-04 | R1 | 938.32h | 938.32h | MBMSE-RANPhysFDD | Ericsson | Lars.Lindbom@ericsson.com | Rel-7 | Patrick |  | MBMSE-RANPhysFDD |  | 34 | RP-070290 |  |
| 7131 | 2268.3 | MBMS TDD Physical layer Enhancements | 117.29d? | 2006-12-15 A | 2007-06-04 A | 100% | 2006-12-15 | 2007-06-04 | 117.29d? | finish no earlier than 2007-06-04 | R1 | 938.32h | 938.32h | MBMSE-RANPhysTDD | IPWireless | Nicholas Anderson | Rel-7 | Patrick |  | MBMSE-RANPhysTDD |  | 34 | RP-070291 |  |
| 7132 | 2268.4 | MBMS Low Chip Rate TDD Physical Layer Enhancement | 127d? | 2007-03-16 A | 2007-09-10 A | 100% | 2007-03-16 | 2007-09-10 | 127d? | finish no earlier than 2007-09-10 | R1 | 1016h | 1016h | MBMSE-RANPhysLCRTDD | RITT | Lin Hui | Rel-7 | Patrick |  | MBMSE-RANPhysLCRTDD |  |  | RP-070292 |  |
| 7133 | 2268.5 | MBMS Mz interface | 260d? | 2006-12-04 A | 2007-11-30 A | 100% | 2006-12-04 | 2007-11-30 | 260d? | finish no earlier than 2007-05-11 | C3 | 2080h | 2080h | MBMSMz | Huawei | Deng Tingting (ttdeng@huawei.com) | Rel-7 | Adrian |  | MBMSMz |  | 34 |  |  |
| 7134 | 2269 | **MBMS - UE Conformance Testing** | 657d? | 2007-06-01 A | 2009-12-04 A | 100% | 2007-06-01 | 2009-12-04 | 657d? |  | R5 | 13848h | 13848h | MBMSE_UEConTest |  |  | Rel-7 | Ingbert |  | MBMSE_UEConTest |  | 40 |  | 21 |
| 7135 | 2269.1 | Conformance Test Aspects – MBMS TDD Physical layer Enhancements – MBSFN for HCR and VHCR TDD | 336d? | 2007-06-01 A | 2008-09-12 A | 100% | 2007-06-01 | 2008-09-12 | 336d? | start no earlier than 2007-06-01 | R5 | 2688h | 2688h | MBMSE-RANPhysTDD_UEConTest | IPWireless | tspeight@ipwireless.com | Rel-7 | Ingbert |  | MBMSE-RANPhysTDD_UEConTest |  |  | RP-080541 |  |
| 7136 | 2269.2 | Conformance Test Aspects – MBMS LCR TDD Physical Layer Enhancement | 342d? | 2008-05-30 A | 2009-09-18 A | 100% | 2008-05-30 | 2009-09-18 | 342d? | finish no earlier than 2009-09-18 | R5 | 2728h | 2728h | MBMSE-RANPhysLCRTDD_UEConTest | CATT | chenxiaozhong@datangmobile.cn | Rel-7 | Ingbert |  | MBMSE-RANPhysLCRTDD_UEConTest |  | 40 | RP-090715 | 21 |
| 7137 | 2269.3 | Conformance Test Aspects – MBSFN for FDD | 397d? | 2008-05-30 A | 2009-12-04 A | 100% | 2008-05-30 | 2009-12-04 | 397d? | finish no earlier than 2009-12-04 | R5 | 3176h | 3176h | MBMSE-UEConTest_RANPhysFDD | Huawei | Xiang Li (trica_li@huawei.com) | Rel-7 | Ingbert |  | MBMSE-UEConTest_RANPhysFDD |  | 40 | RP-091214 | 21 |
| 7138 | 2270 | MBMS User Service Extensions | 392d? | 2005-12-07 A | 2007-06-07 A | 100% | 2005-12-07 | 2007-06-07 | 392d? | finish no earlier than 2007-06-07 | S4 | 3136h | 3136h | MBMSUSE | Ericsson | Thorsten.Lohmar@ericsson.com | Rel-7 | Paolo |  | MBMSUSE |  |  |  |  |
| 7139 | 2271 | **Advanced Global Navigation Satellite System (AGNSS) concept** | 830d? | 2004-06-28 A | 2007-08-31 A | 100% | 2004-06-28 | 2007-08-31 | 830d? |  | S1; S2; GP; R2 | 36129.6h | 36129.6h | LCS3-AGNSS | Alcatel | Michel.monnerat@thalesaleniaspace.com | Rel-7 | Alain |  | LCS3-AGNSS |  |  |  |  |
| 7140 | 2271.1 | Stage 1/2 for Towards AGNSS Concept | 1d? | 2007-02-16 A | 2007-02-16 A | 100% | 2007-02-16 | 2007-02-16 | 1d? | start no earlier than 2007-02-16 | S1; S2 | 16h | 16h | AGNSS | Alcatel | richard.couty@space.alcatel.fr | Rel-7 | Alain |  | AGNSS |  |  |  |  |
| 7141 | 2271.2 | Towards AGNSS Concept | 811.2d? | 2004-06-28 A | 2007-08-31 A | 100% | 2004-06-28 | 2007-08-31 | 811.2d? | finish no earlier than 2007-08-31 | GP | 6489.6h | 6489.6h | AGNSS-GP | Alcatel | richard.couty@space.alcatel.fr | Rel-7 | Paolo |  | AGNSS-GP |  |  |  |  |
| 7142 | 2271.3 | Global Navigation Satellite System (GNSS) in UTRAN | 383d? | 2005-12-15 A | 2007-06-04 A | 100% | 2005-12-15 | 2007-06-04 | 383d? | finish no earlier than 2007-06-04 | R2 | 3064h | 3064h | LCS3-GNSS-UTRAN | France Telecom | alain.abinakhoul@francetelecom.com | Rel-7 | Yong-Jun |  | LCS3-GNSS-UTRAN |  |  | RP-070482 |  |
| 7143 | 2272 | A-GPS Minimum Performance | 351d? | 2006-04-28 A | 2007-08-31 A | 100% | 2006-04-28 | 2007-08-31 | 351d? | finish no earlier than 2007-08-31 | G1; G3 | 5616h | 5616h | GAGR | Spirent | richard.catmur@spirentcom.com | Rel-7 | Paolo |  | GAGR |  |  |  |  |
| 7144 | 2273 | **Unstructured Supplementary Service Data (USSD) message delivery and transfer to USIM** | 376d? | 2004-03-05 A | 2005-08-12 A | 100% | 2004-03-05 | 2005-08-12 | 376d? |  | S1; C6 | 8778.4h | 8778.4h | USSD-USIM | Axalto | Christophe Dubois (cdubois@axalto.com) | Rel-7 | Alain |  | USSD-USIM |  |  |  |  |
| 7145 | 2273.1 | Stage 1 for USSD message delivery and transfer to USIM | 152d? | 2004-03-18 A | 2004-10-15 A | 100% | 2004-03-18 | 2004-10-15 | 152d? | start no earlier than 2004-03-18 | S1 | 1216h | 1216h | USSD-USIM | Axalto | Christophe Dubois (cdubois@axalto.com) | Rel-7 | Alain |  |  |  |  |  |  |
| 7146 | 2273.2 | Alignment with requirements regarding USSD usage | 193.3d? | 2004-03-05 A | 2005-08-12 A | 100% | 2004-03-05 | 2005-08-12 | 193.3d? | finish no earlier than 2005-08-12 | C6 | 1546.4h | 1546.4h | USSD-USIM | Axalto | Christophe Dubois (cdubois@axalto.com) | Rel-7 | Xavier |  |  |  |  |  |  |

Notes:
- 7123: -
- 7124: - / Impacted TSs and TRs: new 22.935
- 7125: SP#41 TR withdrawn. All work transferred to specs / Impacted TSs and TRs: 23.837
- 7126: - / Impacted TSs and TRs: 23.234; 23.271; 23.167
- 7127: -
- 7128: -
- 7129: - / Impacted TSs and TRs: 22.146; 22.246; 22.228
- 7130: - / Impacted TSs and TRs: 25.211; 25.212; 25.213; 25.101; 25.104; 25.331; 25.433; 25.346; 25.306
- 7131: - / Impacted TSs and TRs: 25.346; 25.221; 25.222; 25.223; 25.224; 25.306; 25.331; 25.402; 25.433; 25.102; 25.105; 25.123
- 7132: - / Impacted TSs and TRs: 25.346; 25.221; 25.222; 25.223; 25.224; 25.306; 25.331; 25.402; 25.433; 25.102; 25.105; 25.123
- 7133: - / Impacted TSs and TRs: 29.061
- 7134: Linked to Rel-7 Feature UID_31084 (MBMSE)
- 7135: RP#41 completed / Impacted TSs and TRs: 34.108; 34.122; 34.123-1/2/3
- 7136: RP#45 completed / Impacted TSs and TRs: 34.108; 34.123-1
- 7137: RP#46 completed / Impacted TSs and TRs: 34.108; 34.109; 34.121-1; 34.121-2; 34.123-1; 34.123-2; 34.123-3
- 7138: - / Impacted TSs and TRs: 26.346; 26.946
- 7139: -
- 7140: - / Impacted TSs and TRs: 22.071; 23.271
- 7141: GP#36 completed / Impacted TSs and TRs: 43.030; 43.059; 44.031; 44.035; 44.071; 48.008; 48.018; 48.031; 49.031
- 7142: - / Impacted TSs and TRs: 25.305; 25.331; 25.306; 25.413; 25.423; 25.433; 25.453; 25.302; 25.215; 25.401; 25.402; 25.450; 25.452
- 7143: - / Impacted TSs and TRs: 45.005; 51.010
- 7144: -
- 7145: - / Impacted TSs and TRs: 22.090
- 7146: - / Impacted TSs and TRs: 31.111; 31.115; 31.130

| ID | WBS | Task | Type | Duration | Start | Finish | Complete | Baseline start | Baseline finish | Baseline duration | Constraint | Resources | Work | Actual work | Acronym | WI rapporteur name | WI rapporteur e-mail | Release | MCC resp | Acronym_3GU_Export | Impacted TSs and TRs | PCG approved | TSG approved | TSG stopped |
| --- | --- | --- | --- | --- | --- | --- | --- | --- | --- | --- | --- | --- | --- | --- | --- | --- | --- | --- | --- | --- | --- | --- | --- | --- |
| 7147 | 2274 | **Combinational Services** |  | 296d? | 2005-01-17 A | 2006-03-06 A | 100% | 2005-01-17 | 2006-03-06 | 296d? |  | S1; S2; C1; S4 | 14648h | 14648h | CSICS | TeliaSonera | Robert.Frank@teliasonera.com | Rel-7 | Alain | CSICS |  |  |  |  |
| 7148 | 2274.1 | Stage 1 for CSICS |  | 104d? | 2005-01-17 A | 2005-06-09 A | 100% | 2005-01-17 | 2005-06-09 | 104d? | start no earlier than 2005-01-17 | S1 | 832h | 832h | CSICS | TeliaSonera | Robert.Frank@teliasonera.com | Rel-7 | Alain |  | 22.279 |  |  |  |
| 7149 | 2274.2 | Stage 2 for CSICS |  | 130d? | 2005-01-17 A | 2005-07-15 A | 100% | 2005-01-17 | 2005-07-15 | 130d? | start no earlier than 2005-01-17 | S2 | 1040h | 1040h | CSICS | TeliaSonera | Robert.Frank@teliasonera.com | Rel-7 | Maurice |  | 23.279 |  |  |  |
| 7150 | 2274.3 | Stage 3 for CSICS CN aspects |  | 221d? | 2005-05-02 A | 2006-03-06 A | 100% | 2005-05-02 | 2006-03-06 | 221d? | finish no earlier than 2006-03-06 | C1 | 1768h | 1768h | CSICS | Vodafone | peter.dawes@vodafone.com | Rel-7 | Frederic |  | 24.879; 24.279; 24.229; 24.008 |  |  |  |
| 7151 | 2274.4 | Stage 3 for codec aspects |  | 192d? | 2005-03-15 A | 2005-12-07 A | 100% | 2005-03-15 | 2005-12-07 | 192d? | finish no earlier than 2005-12-07 | S4 | 1536h | 1536h | CSICS-Codec | Ericsson | Per.Frojdh@ericsson.com | Rel-7 | Paolo | CSICS-Codec | 26.141; 26.235 |  |  |  |
| 7152 | 2275 | **CAMEL Trunk Triggers** |  | 251d? | 2004-12-17 A | 2005-12-05 A | 100% | 2004-12-17 | 2005-12-05 | 251d? |  | S1; C4 | 8032h | 8032h | TTCAMEL | Nortel | Amar Deol (deola@nortelnetworks.com) | Rel-7 | Alain | TTCAMEL |  |  |  |  |
| 7153 | 2275.1 | Stage 1 for CAMEL Trunk Triggers |  | 251d? | 2004-12-17 A | 2005-12-05 A | 100% | 2004-12-17 | 2005-12-05 | 251d? |  | S1 | 2008h | 2008h | TTCAMEL | Nortel | Amar Deol (deola@nortelnetworks.com) | Rel-7 | Alain |  | 22.078 |  |  |  |
| 7154 | 2275.2 | CAMEL Trunk Originated Trigger Detection Points |  | 251d? | 2004-12-17 A | 2005-12-05 A | 100% | 2004-12-17 | 2005-12-05 | 251d? | start no earlier than 2004-12-17 | C4 | 2008h | 2008h | CamelR7 | Nortel | David Hutton (dhutton@nortel.com) | Rel-7 | Kimmo | CamelR7 |  |  |  |  |
| 7155 | 2276 | **IMS Service Brokering enhancements** |  | 69d? | 2005-12-07 A | 2006-03-13 A | 100% | 2005-12-07 | 2006-03-13 | 69d? |  | S1 | 1104h | 1104h | ISB | Telcordia | jbakker@telcordia.com | Rel-7 | Alain | ISB | 22.228 |  |  |  |
| 7156 | 2276.1 | Stage 1 for ISB |  | 69d? | 2005-12-07 A | 2006-03-13 A | 100% | 2005-12-07 | 2006-03-13 | 69d? | finish no earlier than 2006-03-13 | S1 | 552h | 552h | ISB-s1 | Telcordia | jbakker@telcordia.com | Rel-7 | Alain | ISB-s1 | 22.228 |  |  |  |
| 7157 | 2277 | **Enhancements of VGCS for public authority officials** |  | 731d? | 2004-08-27 A | 2007-06-15 A | 100% | 2004-08-27 | 2007-06-15 | 731d? |  | S1; C1; C4; G2 | 49312h | 49312h | EVGCS |  |  | Rel-7 | Alain | EVGCS | 43.068; 44.068; 24.008; 29.002 | 38 | 75 |  |
| 7158 | 2277.1 | Stage 1 for Enhancements of VGCS for public authority officials | milestone | 0d? | 2004-08-27 A | 2004-08-27 A | 100% | 2004-08-27 | 2004-08-27 | 0d? | finish no earlier than 2004-08-27 | S1 |  |  | EVGCS | Siemens | joerg.swetina@neclab.eu | Rel-7 | Alain |  | 42.068; 43.068 |  |  |  |
| 7159 | 2277.2 | **Architecture and protocol aspects** |  | 731d? | 2004-08-27 A | 2007-06-15 A | 100% | 2004-08-27 | 2007-06-15 | 731d? |  | C1; C4 | 20752h | 20752h | EVGCS | Siemens | robert.zaus@nsn.com | Rel-7 | Frederic |  | 43.068; 44.068 |  |  |  |
| 7160 | 2277.2.1 | CT1 aspects of EVGCS |  | 731d? | 2004-08-27 A | 2007-06-15 A | 100% | 2004-08-27 | 2007-06-15 | 731d? | finish no earlier than 2006-09-15 | C1 | 5848h | 5848h | EVGCS | Siemens | robert.zaus@nsn.com | Rel-7 | Frederic |  | 43.068; 44.068; 24.008 |  |  |  |
| 7161 | 2277.2.2 | CT4 aspects of EVGCS |  | 401d? | 2004-08-27 A | 2006-03-10 A | 100% | 2004-08-27 | 2006-03-10 | 401d? | finish no earlier than 2006-03-10 | C4 | 3208h | 3208h | EVGCS | Siemens | robert.zaus@nsn.com | Rel-7 | Kimmo |  | 29.002 |  |  |  |
| 7162 | 2277.3 | GERAN2 aspects of EVGCS |  | 646d? | 2004-08-27 A | 2007-02-16 A | 100% | 2004-08-27 | 2007-02-16 | 646d? | finish no earlier than 2007-02-16 | G2 | 5168h | 5168h | EVGCS | Siemens | kenneth.isaacs@roke.co.uk | Rel-7 | Gert |  |  | 38 | 75 |  |
| 7163 | 2278 | **Improvements of VGCS for parallel use of services** |  | 523d? | 2005-03-15 A | 2007-03-15 A | 100% | 2005-03-15 | 2007-03-15 | 523d? |  | S1 | 12230.2h | 12230.2h | IVGCS |  |  | Rel-7 | Alain | IVGCS |  |  |  |  |
| 7164 | 2278.1 | Service Requirements for VGCS improvements |  | 62d? | 2005-03-15 A | 2005-06-08 A | 100% | 2005-03-15 | 2005-06-08 | 62d? | finish no earlier than 2005-06-08 | S1 | 496h | 496h | IVGCS | T-Mobile | kurt.bischinger@t-mobile.at | Rel-7 | Alain |  | 42.068 |  |  |  |
| 7165 | 2278.2 | Stage 2 modifications for VGCS improvements |  | 335d? | 2005-12-01 A | 2007-03-14 A | 100% | 2005-12-01 | 2007-03-14 | 335d? | start no earlier than 2005-12-01 | C1 | 2680h | 2680h | IVGCS | T-Mobile | kurt.bischinger@t-mobile.at | Rel-7 | Frederic |  | 43.068 |  |  |  |
| 7166 | 2278.3 | **Protocol aspects** |  | 336d? | 2005-12-01 A | 2007-03-15 A | 100% | 2005-12-01 | 2007-03-15 | 336d? |  | C1 | 5376h | 5376h | IVGCS | T-Mobile | Dieter Jacobsohn | Rel-7 | Frederic |  | 44.068 |  |  |  |
| 7167 | 2278.3.1 | CT1 aspects of IVGCS |  | 336d? | 2005-12-01 A | 2007-03-15 A | 100% | 2005-12-01 | 2007-03-15 | 336d? | finish no earlier than 2007-03-15 | C1 | 2688h | 2688h | IVGCS | T-Mobile |  | Rel-7 | Frederic |  | 43.068; 44.068 |  |  |  |
| 7168 | 2278.3.2 | Deleted - CT4 aspects of IVGCS | milestone | 0d? | 2007-03-09 A | 2007-03-09 A | 100% | 2007-03-09 | 2007-03-09 | 0d? | finish no earlier than 2007-03-09 | C4 |  |  | IVGCS-St3-c4 | T-mobile |  | Rel-7 | Kimmo | IVGCS-St3-c4 | 29.002 |  |  | CP-35 |
| 7169 | 2279 | **Open Service Access (OSA) Rel-7** |  | 584d? | 2005-03-15 A | 2007-06-08 A | 100% | 2005-03-15 | 2007-06-08 | 584d? |  | S1; C5 | 29776h | 29776h | OSA7 | AePONA | eamonn.murray@aepona.com | Rel-7 | Alain | OSA7 |  |  |  |  |
| 7170 | 2279.1 | **OSA Service Broker** |  | 449d? | 2005-03-15 A | 2006-12-01 A | 100% | 2005-03-15 | 2006-12-01 | 449d? |  | S1; C5 | 10176h | 10176h | OSA7-SB | AePONA | eamonn.murray@aepona.com | Rel-7 | Alain | OSA7-SB |  |  |  |  |
| 7171 | 2279.1.1 | Service Requirements for OSA Service Broker |  | 62d? | 2005-03-15 A | 2005-06-08 A | 100% | 2005-03-15 | 2005-06-08 | 62d? | finish no earlier than 2005-06-08 | S1 | 496h | 496h | OSA7 | AePONA | eamonn.murray@aepona.com | Rel-7 | Alain |  | 22.127 |  |  |  |
| 7172 | 2279.1.2 | Stage 2 OSA API Service Brokering |  | 156d? | 2006-04-28 A | 2006-12-01 A | 100% | 2006-04-28 | 2006-12-01 | 156d? |  | C5 | 1248h | 1248h | OSA7 | AePONA | damian.oneill@aepona.com | Rel-7 | Kimmo |  | 23.198 |  |  |  |
| 7173 | 2279.1.3 | Stage 3 OSA API Service Brokering |  | 156d? | 2006-04-28 A | 2006-12-01 A | 100% | 2006-04-28 | 2006-12-01 | 156d? | finish no earlier than 2006-12-01 | C5 | 1248h | 1248h | OSA7 | AePONA | damian.oneill@aepona.com | Rel-7 | Kimmo |  | 29.198-16 |  |  |  |

Notes:
- 7147: -
- 7148: -
- 7149: -
- 7150: -
- 7151: -
- 7152: -
- 7153: -
- 7154: -
- 7155: No CR submitted in rel-8 (according to CR database).
- 7156: No Rel-8 changes
- 7157: Moved from Rel-6 UID_50563 Enhancements of VGCS in public networks for communication of public authority officials
- 7158: Voice Group Call Service
- 7159: -
- 7160: -
- 7161: -
- 7162: -
- 7163: Voice Group Call Service
- 7164: -
- 7165: -
- 7166: Previous name (before CT32) was Architecture and protocol aspects
- 7167: -
- 7168: CT4#33 stage 2 solution is still open.
- 7169: -
- 7170: -
- 7171: -
- 7172: -
- 7173: -

| ID | WBS | Task | Type | Duration | Start | Finish | Complete | Baseline start | Baseline finish | Baseline duration | Constraint | Resources | Work | Actual work | Acronym | Impacted TSs and TRs | WI rapporteur name | WI rapporteur e-mail | Release | MCC resp | TSG approved | Acronym_3GU_Export | TSG stopped | Status Report |
| --- | --- | --- | --- | --- | --- | --- | --- | --- | --- | --- | --- | --- | --- | --- | --- | --- | --- | --- | --- | --- | --- | --- | --- | --- |
| 7174 | 2279.2 | **Rel-7 OSA Stage 2/3 enhancements** |  | 291d? | 2006-04-28 A | 2007-06-08 A | 100% | 2006-04-28 | 2007-06-08 | 291d? |  | C5 | 10256h | 10256h | OSA7 | 29.198/9; 23.198 | AePONA | damian.oneill@aepona.com | Rel-7 | Kimmo |  |  |  |  |
| 7175 | 2279.2.1 | Parlay X Message Broadcast Web Service |  | 156d? | 2006-04-28 A | 2006-12-01 A | 100% | 2006-04-28 | 2006-12-01 | 156d? | finish no earlier than 2006-12-01 | C5 | 1248h | 1248h | OSA7 | 29.199-15; 23.198 | ETRI |  | Rel-7 | Kimmo |  |  |  |  |
| 7176 | 2279.2.2 | Parlay X Geocoding Web Service |  | 156d? | 2006-04-28 A | 2006-12-01 A | 100% | 2006-04-28 | 2006-12-01 | 156d? | finish no earlier than 2006-12-01 | C5 | 1248h | 1248h | OSA7 | 29.199-16; 23.198 | ETRI |  | Rel-7 | Kimmo |  |  |  |  |
| 7177 | 2279.2.3 | Parlay X Application driven QoS Web Service |  | 226d? | 2006-04-28 A | 2007-03-09 A | 100% | 2006-04-28 | 2007-03-09 | 226d? | finish no earlier than 2007-03-09 | C5 | 1808h | 1808h | OSA7 | 29.199-17; 23.198 | BT |  | Rel-7 | Kimmo |  |  |  |  |
| 7178 | 2279.2.4 | Parlay-X Device Capabilities and Configuration |  | 162d? | 2006-10-26 A | 2007-06-08 A | 100% | 2006-10-26 | 2007-06-08 | 162d? | finish no earlier than 2007-06-09 | C5 | 1296h | 1296h | OSA7 | 29.199-18; 23.198 | Telenor |  | Rel-7 | Kimmo | 34 |  |  |  |
| 7179 | 2279.2.5 | Parlay-X Multimedia Streaming Session Management Web Service |  | 97d? | 2006-10-26 A | 2007-03-09 A | 100% | 2006-10-26 | 2007-03-09 | 97d? | start no earlier than 2006-10-26 | C5 | 776h | 776h | OSA7 | 29.199-19; 23.198 | Telenor |  | Rel-7 | Kimmo | 34 |  |  |  |
| 7180 | 2279.2.6 | Parlay-X Multimedia Multicast Control Web Service |  | 97d? | 2006-10-26 A | 2007-03-09 A | 100% | 2006-10-26 | 2007-03-09 | 97d? | start no earlier than 2006-10-26 | C5 | 776h | 776h | OSA7 | 29.199-20; 23.198 | ETRI |  | Rel-7 | Kimmo | 34 |  |  |  |
| 7181 | 2279.2.7 | OSA API Conference Call Control SCF |  | 97d? | 2006-10-26 A | 2007-03-09 A | 100% | 2006-10-26 | 2007-03-09 | 97d? | start no earlier than 2006-10-26 | C5 | 776h | 776h | OSA7 | 29.198-04-5; 23.198 | Ericsson |  | Rel-7 | Kimmo | 34 |  |  |  |
| 7182 | 2280 | **Selective Disabling of UE Capabilities** |  | 624.36d? | 2005-01-24 A | 2007-06-15 A | 100% | 2005-01-24 | 2007-06-15 | 624.36d? |  | S1; S2; C1 | 22341.5h | 22341.5h | SDoUE |  | Motorola |  | Rel-7 | Alain |  | SDoUE |  |  |
| 7183 | 2280.1 | Stage 1 of SDoUE |  | 393.6d? | 2005-01-24 A | 2006-12-08 A | 100% | 2005-01-24 | 2006-12-08 | 393.6d? | finish no earlier than 2006-12-08 | S1 | 3148.8h | 3148.8h | SDoUE-CR | 22.011 | Motorola |  | Rel-7 | Alain |  | SDoUE-CR |  |  |
| 7184 | 2280.2 | Deleted - TR on different possible architectures |  | 195d? | 2005-03-21 A | 2005-12-16 A | 100% | 2005-03-21 | 2005-12-16 | 195d? | finish no earlier than 2005-12-16 | S2 | 1560h | 1560h | SDoUE-FS | 23.805 abandonned at SP-30; descendant C1 24.305 | Vodafone | Gavin.Wong@vodafone.com | Rel-7 | Maurice |  | SDoUE-FS | SP-30 |  |
| 7185 | 2280.3 | Stage 3 of SDoUE |  | 331d? | 2006-03-10 A | 2007-06-15 A | 100% | 2006-03-10 | 2007-06-15 | 331d? | finish no earlier than 2007-06-15 | C1 | 2648h | 2648h | SDoUE | 24.305 | Ericsson | christian.herrero@ericsson.com | Rel-7 | Frederic |  |  |  |  |
| 7186 | 2281 | **Network selection enhancements (NSP)** |  | 328d? | 2006-03-15 A | 2007-06-15 A | 100% | 2006-03-15 | 2007-06-15 | 328d? |  | S1 | 6320h | 6320h | NSP |  | O2 | chris.friel@O2.com | Rel-7 | Alain |  | NSP |  |  |
| 7187 | 2281.1 | Stage 1 of NSP |  | 191d? | 2006-03-15 A | 2006-12-06 A | 100% | 2006-03-15 | 2006-12-06 | 191d? | start no earlier than 2006-03-15 | S1 | 1528h | 1528h | NSP-TS | 22.101; 22.011; 23.122; 24.008; 25.304; 31.102; 45.008 | O2 | chris.friel@O2.com | Rel-7 | Alain |  | NSP-TS |  |  |
| 7188 | 2281.2 | Procedural aspects of NSP |  | 271d? | 2006-06-02 A | 2007-06-15 A | 100% | 2006-06-02 | 2007-06-15 | 271d? | finish no earlier than 2007-06-15 | C1 | 2168h | 2168h | NSP-CR | 23.122; 24.008; 31.102 | Motorola | Andrew Howell | Rel-7 | Frederic |  | NSP-CR |  |  |
| 7189 | 2282 | Network selection enhancements (NSP) - UE Conformance Testing |  | 396d? | 2007-06-01 A | 2008-12-05 A | 100% | 2007-06-01 | 2008-12-05 | 396d? | finish no earlier than 2008-12-05 | R5 | 3168h | 3168h | NSP-CR_UEConTest | 34.108; 34.123-1; 34.123-2; 34.123-3 | Nokia | jarkko.hellsten@nokia.com | Rel-7 | Ingbert |  | NSP-CR_UEConTest |  | RP-080819 |
| 7190 | 2283 | **Access Class Barring and Overload Protection** |  | 650d? | 2004-03-15 A | 2006-09-08 A | 100% | 2004-03-15 | 2006-09-08 | 650d? |  | S2; C1 | 13968h | 13968h | ACBOP | 23.898 | Vodafone | chris.pudney@vodafone.com | Rel-7 | Maurice |  | ACBOP |  |  |
| 7191 | 2283.1 | TR on Stage 2 |  | 274d? | 2004-03-15 A | 2005-03-31 A | 100% | 2004-03-15 | 2005-03-31 | 274d? | finish no earlier than 2005-03-31 | S2 | 2192h | 2192h | ACBOP | 23.898 | NTT DoCoMo | Jean-Jacques Davidian (davidian@docomo.fr) | Rel-7 | Maurice |  |  |  |  |
| 7192 | 2283.2 | Stage 3 CN aspects of ACBOP |  | 172d? | 2005-06-06 A | 2006-01-31 A | 100% | 2005-06-06 | 2006-01-31 | 172d? | start no earlier than 2005-06-06 | C1 | 1376h | 1376h | ACBOP | 24.008 |  |  | Rel-7 | Frederic |  |  |  |  |
| 7193 | 2283.3 | Deleted - Potential impact on Iu interface Overload functionality | milestone | 0d? | 2004-03-15 A | 2004-03-15 A | 100% | 2004-03-15 | 2004-03-15 | 0d? | finish no earlier than 2004-03-15 | RP |  |  | ACBOP | 25.413 |  |  | Rel-7 | Issam |  |  | RP-25 |  |
| 7194 | 2283.4 | Deleted - Extra ACBOP information in RAN | milestone | 0d? | 2004-03-15 A | 2004-03-15 A | 100% | 2004-03-15 | 2004-03-15 | 0d? | finish no earlier than 2004-03-15 | RP |  |  | ACBOP | 25.331 |  |  | Rel-7 | Issam |  |  | RP-25 |  |
| 7195 | 2283.5 | Deleted - Extra ACBOP information in GERAN | milestone | 0d? | 2006-09-08 A | 2006-09-08 A | 100% | 2006-09-08 | 2006-09-08 | 0d? | start no earlier than 2006-09-08 | GP |  |  | ACBOP | 44.018 |  |  | Rel-7 | Paolo |  |  | RP-33 |  |
| 7196 | 2284 | **System enhancements for Fixed Broadband access to IMS** |  | 2117d? | 2003-11-05 A | 2011-12-09 A | 100% | 2003-11-05 | 2011-12-09 | 2117d? |  | S2; S3; S5; C1; C3; C4; IETF | 369944h | 369944h | FBI |  |  |  | Rel-7 | Maurice |  | FBI |  |  |
| 7197 | 2284.1 | **TISPAN Rel 1 related aspects** |  | 2117d? | 2003-11-05 A | 2011-12-09 A | 100% | 2003-11-05 | 2011-12-09 | 2117d? |  | S2; S3; C1; C3; C4; IETF | 239320h | 239320h | FBI-TIS1 |  |  |  | Rel-7 | Maurice |  | FBI-TIS1 |  |  |
| 7198 | 2284.1.1 | Stage 2 of FBI for TISPAN R1 |  | 365d? | 2004-10-14 A | 2006-03-08 A | 100% | 2004-10-14 | 2006-03-08 | 365d? | start no earlier than 2004-10-14 | S2 | 2920h | 2920h |  |  |  |  | Rel-7 | Maurice |  |  |  |  |

Notes:
- 7174: CP#34 updated WID CP-060607=>CP-070200
- 7175: -
- 7176: -
- 7177: -
- 7178: -
- 7179: -
- 7180: -
- 7181: -
- 7182: Moved from FS section Feb 06
- 7183: Moved from FS section Feb 06
- 7184: Moved from FS section Feb 06. Abandoned at SP-30
- 7185: -
- 7186: -
- 7187: -
- 7188: -
- 7189: RP#42 completed. Testing for Feature UID_7041 (NSP-CR)
- 7190: -
- 7191: -
- 7192: -
- 7193: -
- 7194: -
- 7195: -
- 7196: -
- 7197: -
- 7198: -

| ID | WBS | Task | Duration | Start | Finish | Complete | Baseline start | Baseline finish | Baseline duration | Constraint | Resources | Work | Actual work | WI rapporteur name | WI rapporteur e-mail | Release | MCC resp | PCG approved | TSG approved | Acronym | Acronym_3GU_Export | Special Focus Doc | TSG stopped |
| --- | --- | --- | --- | --- | --- | --- | --- | --- | --- | --- | --- | --- | --- | --- | --- | --- | --- | --- | --- | --- | --- | --- | --- |
| 7199 | 2284.1.2 | **Protocol impact of FBI for TISPAN R1** | 2117d? | 2003-11-05 A | 2011-12-09 A | 100% | 2003-11-05 | 2011-12-09 | 2117d? |  | S3; C1; C3; C4; IETF | 133840h | 133840h | Siemens | peter.leis@nsn.com | Rel-7 | Frederic |  |  |  |  |  |  |
| 7200 | 2284.1.2.1 | (IETF) CT aspects of FBI for TISPAN R1 | 2117d? | 2003-11-05 A | 2011-12-09 A | 100% | 2003-11-05 | 2011-12-09 | 2117d? | start no earlier than 2003-11-05 | C1-IETF; C3-IETF | 33872h | 33872h | Roland Jesske |  | Rel-7 | Frederic | 27 | 52 |  |  |  |  |
| 7201 | 2284.1.2.2 | CT1 aspects of FBI for TISPAN R1 | 802d? | 2003-11-05 A | 2006-11-30 A | 100% | 2003-11-05 | 2006-11-30 | 802d? | finish no earlier than 2006-11-30 | C1 | 6416h | 6416h | Siemens | peter.leis@nsn.com | Rel-7 | Frederic |  |  |  |  |  |  |
| 7202 | 2284.1.2.3 | CT3 aspects of FBI for TISPAN R1 | 808d? | 2003-11-05 A | 2006-12-08 A | 100% | 2003-11-05 | 2006-12-08 | 808d? | finish no earlier than 2006-12-08 | C3 | 6464h | 6464h | Siemens | peter.leis@nsn.com | Rel-7 | Adrian |  |  |  |  |  |  |
| 7203 | 2284.1.2.4 | CT4 aspects of FBI for TISPAN R1 | 301d? | 2006-01-13 A | 2007-03-09 A | 100% | 2006-01-13 | 2007-03-09 | 301d? | finish no earlier than 2007-03-09 | C4 | 2408h | 2408h | Siemens | peter.leis@nsn.com | Rel-7 | Kimmo |  |  | FBI-TIS1-st3-c4 | FBI-TIS1-st3-c4 |  |  |
| 7204 | 2284.1.3 | Security Enhancements for FBI | 118d? | 2005-06-28 A | 2005-12-08 A | 100% | 2005-06-28 | 2005-12-08 | 118d? | start no earlier than 2005-06-28 | S3 | 944h | 944h | Ericsson | Bengt.Sahlin@ericsson.com | Rel-7 | Mirko |  |  | FBI-ISE | FBI-ISE |  |  |
| 7205 | 2284.2 | **PacketCable Related aspects** | 291d? | 2006-02-01 A | 2007-03-14 A | 100% | 2006-02-01 | 2007-03-14 | 291d? |  | S2; S5; C1 | 12072h | 12072h | CableLabs | Bernie McKibben (b.mckibben@cablelabs.com) | Rel-7 | Maurice |  |  | FBI-PCBL | FBI-PCBL |  |  |
| 7206 | 2284.2.1 | Stage 1,2 of FBI for PacketCable | 228d? | 2006-02-01 A | 2006-12-15 A | 100% | 2006-02-01 | 2006-12-15 | 228d? | finish no earlier than 2006-12-15 | S2 | 1824h | 1824h | CableLabs | Bernie McKibben (b.mckibben@cablelabs.com) | Rel-7 | Maurice |  |  |  |  |  |  |
| 7207 | 2284.2.2 | Protocol impact of FBI for PacketCable | 228d? | 2006-05-01 A | 2007-03-14 A | 100% | 2006-05-01 | 2007-03-14 | 228d? | finish no earlier than 2007-03-15 | C1 | 1824h | 1824h |  |  | Rel-7 | Frederic |  |  |  |  |  |  |
| 7208 | 2284.2.3 | SA5 Charging aspects of FBI for PacketCable | 180d? | 2006-03-31 A | 2006-12-07 A | 100% | 2006-03-31 | 2006-12-07 | 180d? | finish no earlier than 2006-12-07 | S5 | 1440h | 1440h | CableLabs | Bernie McKibben (b.mckibben@cablelabs.com) | Rel-7 | Mirko |  |  | FBI-PCBL-CH | FBI-PCBL-CH |  |  |
| 7209 | 2285 | **Support of SMS over generic 3GPP IP access** | 696d? | 2004-10-14 A | 2007-06-14 A | 100% | 2004-10-14 | 2007-06-14 | 696d? |  | S2; C4; C1 | 37544h | 37544h | Huawei | zhangwenlin@huawei.com | Rel-7 | Maurice |  |  | SMSIP | SMSIP | WLAN |  |
| 7210 | 2285.1 | FS on SMSIP | 173d? | 2004-10-14 A | 2005-06-13 A | 100% | 2004-10-14 | 2005-06-13 | 173d? | start no earlier than 2004-10-14 | S2 | 1384h | 1384h | Huawei | zhangwenlin@huawei.com | Rel-7 | Maurice |  |  |  |  | WLAN |  |
| 7211 | 2285.2 | Stage 2 for SMSIP | 333d? | 2005-06-08 A | 2006-09-15 A | 100% | 2005-06-08 | 2006-09-15 | 333d? | finish no earlier than 2006-09-15 | S2 | 2664h | 2664h | Huawei | zhangwenlin@huawei.com | Rel-7 | Maurice |  |  |  |  | WLAN |  |
| 7212 | 2285.3 | **Stage 3 for SMSIP** | 527d? | 2005-06-08 A | 2007-06-14 A | 100% | 2005-06-08 | 2007-06-14 | 527d? |  | C4; C1 | 16792h | 16792h | Nokia | jari.jansson@nokia.com | Rel-7 | Kimmo |  |  | SMSIP-St3 | SMSIP-St3 | WLAN |  |
| 7213 | 2285.3.1 | CT1 aspects for SMSIP | 527d? | 2005-06-08 A | 2007-06-14 A | 100% | 2005-06-08 | 2007-06-14 | 527d? | finish no earlier than 2007-06-15 | C1 | 4216h | 4216h | Nokia | jari.jansson@nokia.com | Rel-7 | Frederic |  |  |  |  | WLAN |  |
| 7214 | 2285.3.2 | CT4 aspects for SMSIP | 518d? | 2005-06-08 A | 2007-06-01 A | 100% | 2005-06-08 | 2007-06-01 | 518d? | finish no earlier than 2007-06-01 | C4 | 4144h | 4144h | Nokia | jari.jansson@nokia.com | Rel-7 | Kimmo |  |  | SMSIP-St3-c4 | SMSIP-St3-c4 | WLAN |  |
| 7215 | 2286 | **Evolution of Policy Control and Charging** | 817d? | 2004-10-14 A | 2007-11-30 A | 100% | 2004-10-14 | 2007-11-30 | 817d? |  | S2; S5; C3; C1 | 54112h | 54112h | Nokia | balazs.bertenyi@nsn.com | Rel-7 | Maurice |  |  | PCC | PCC |  |  |
| 7216 | 2286.1 | Deleted - TR for PCC | 315d? | 2004-10-14 A | 2005-12-29 A | 100% | 2004-10-14 | 2005-12-29 | 315d? | finish no earlier than 2005-12-28 | S2 | 2520h | 2520h | Nokia | balazs.bertenyi@nsn.com | Rel-7 | Maurice |  |  |  |  |  | SP-33 |
| 7217 | 2286.2 | Stage 2 for PCC | 315d? | 2005-07-04 A | 2006-09-15 A | 100% | 2005-07-04 | 2006-09-15 | 315d? | finish no earlier than 2006-09-15 | S2 | 2520h | 2520h | Nokia | balazs.bertenyi@nsn.com | Rel-7 | Maurice |  |  |  |  |  |  |
| 7218 | 2286.3 | Evolution of policy control and flow based bearer level charging | 109d? | 2006-08-01 A | 2006-12-29 A | 100% | 2006-08-01 | 2006-12-29 | 109d? | start no earlier than 2006-08-01 | S2 | 872h | 872h | Nokia | balazs.bertenyi@nsn.com | Rel-7 | Maurice |  |  |  |  |  |  |
| 7219 | 2286.4 | SA5 Charging aspects of PCC | 316d? | 2006-03-31 A | 2007-06-15 A | 100% | 2006-03-31 | 2007-06-15 | 316d? | finish no earlier than 2007-06-15 | S5 | 2528h | 2528h | Orange | alain.bibas@orange-ft.com | Rel-7 | Mirko |  |  | PCC-CH | PCC-CH |  |  |
| 7220 | 2286.5 | Gx reference point for Policy and Charging Control | 521d? | 2005-12-02 A | 2007-11-30 A | 100% | 2005-12-02 | 2007-11-30 | 521d? | finish no earlier than 2007-09-14 | C3 | 4168h | 4168h | Siemens | Thomas.Belling@nsn.com | Rel-7 | Adrian |  |  | PCC-Gx | PCC-Gx |  |  |
| 7221 | 2286.6 | **Rx reference point for PCC CT3 aspects** | 521d? | 2005-12-02 A | 2007-11-30 A | 100% | 2005-12-02 | 2007-11-30 | 521d? |  | C3; C1 | 15360h | 15360h | Ericsson | j.javier.pastor@ericsson.com | Rel-7 | Adrian |  |  | PCC-Rx | PCC-Rx |  |  |
| 7222 | 2286.6.1 | PCC-Rx CT3 aspects | 521d? | 2005-12-02 A | 2007-11-30 A | 100% | 2005-12-02 | 2007-11-30 | 521d? | finish no earlier than 2007-09-14 | C3 | 4168h | 4168h | Ericsson | j.javier.pastor@ericsson.com | Rel-7 | Adrian |  |  | PCC-Rx-c3 | PCC-Rx-c3 |  |  |
| 7223 | 2286.6.2 | PCC-Rx CT1 aspects | 357d? | 2005-12-02 A | 2007-06-15 A | 100% | 2005-12-02 | 2007-06-15 | 357d? | finish no earlier than 2007-06-15 | C1 | 2856h | 2856h | Ericsson | j.javier.pastor@ericsson.com | Rel-7 | Frederic |  |  | PCC-Rx-Gx-c1 | PCC-Rx-Gx-c1 |  |  |

Notes:
- 7199: -
- 7200: CP#54 completed / Impacted TSs and TRs: RFC 6432 (was draft-jesske-dispatch-update3326-reason-responses)
- 7201: - / Impacted TSs and TRs: 24.819; 24.229
- 7202: - / Impacted TSs and TRs: 29.163; 29.209
- 7203: CT4#32: a set of CRs on FBI for cable labs / Impacted TSs and TRs: 29.229
- 7204: Duplicated entry ("ACCSEC2", "Access Security Enhancements", SP-040865) deleted by A.Sultan / Impacted TSs and TRs: 33.203
- 7205: -
- 7206: - / Impacted TSs and TRs: 22.228; 23.228
- 7207: -
- 7208: 03/2006 SP#31 WID approved / Impacted TSs and TRs: 32.240; 32.260; 32.298; 32.299
- 7209: SP#33 updated WID (removed MMS)
- 7210: SP#33 updated WID / Impacted TSs and TRs: 23.804
- 7211: SP#33 updated WID / Impacted TSs and TRs: 23.204
- 7212: CP#34 updated WID
- 7213: CP#34 updated WID / Impacted TSs and TRs: 23.040; 24.229
- 7214: CP#34 updated WID / Impacted TSs and TRs: 23.008; 29.002
- 7215: SP-29 approved WID. SP-31 updated WID adding SA5 charging. 23.125 will be discontinued from Rel-7.
- 7216: SP-30: S2 has no intention for TR completion / Impacted TSs and TRs: 23.803
- 7217: SP-29 approved WID. SP-31 updated WID. 23.125 will be discontinued from Rel-7. / Impacted TSs and TRs: 23.203
- 7218: SP-29 approved WID. SP-31 updated WID. 23.125 will be discontinued from Rel-7. / Impacted TSs and TRs: 23.207; 23.002; 23.228
- 7219: SP-31 updated WID with SA5 charging. / Impacted TSs and TRs: 32.250; 32.251; 32.298; 32.299
- 7220: - / Impacted TSs and TRs: 29.212 (not progressed to Rel-7: 29.210; 29.207; 29.208)
- 7221: WID approved at CP#30, Revised at CP#31, Revised at CP#33
- 7222: - / Impacted TSs and TRs: 29.213; 29.214 (not progressed to Rel-7: 29.209; 29.211)
- 7223: - / Impacted TSs and TRs: 24.229

| ID | WBS | Task | Type | Duration | Start | Finish | Complete | Baseline start | Baseline finish | Baseline duration | Constraint | Resources | Work | Actual work | Acronym | WI rapporteur name | WI rapporteur e-mail | Release | MCC resp | Special Focus Doc | Acronym_3GU_Export | Impacted TSs and TRs | TSG stopped | TSG approved |
| --- | --- | --- | --- | --- | --- | --- | --- | --- | --- | --- | --- | --- | --- | --- | --- | --- | --- | --- | --- | --- | --- | --- | --- | --- |
| 7224 | 2287 | **Voice Call Continuity between CS and IMS (incl. I-WLAN)** |  | 641d? | 2004-12-31 A | 2007-06-15 A | 100% | 2004-12-31 | 2007-06-15 | 641d? |  | S2; S1; S5; C1; C4 | 43592h | 43592h | VCC | Alcatel-Lucent | Keith Drage (drage@alcatel-lucent.com) | Rel-7 | Maurice | WLAN | VCC |  |  |  |
| 7225 | 2287.1 | TR for Voice Call Continuity between CS and IMS (incl. I-WLAN) |  | 245d? | 2004-12-31 A | 2005-12-08 A | 100% | 2004-12-31 | 2005-12-08 | 245d? | finish no earlier than 2005-12-08 | S2 | 1960h | 1960h |  | Alcatel-Lucent | andy.bennett@alcatel-lucent.com | Rel-7 | Maurice | WLAN |  | 23.806 |  |  |
| 7226 | 2287.2 | Stage 1 for Voice Call Continuity between CS and IMS (incl. I-WLAN) |  | 140d? | 2005-03-17 A | 2005-09-28 A | 100% | 2005-03-17 | 2005-09-28 | 140d? | finish no earlier than 2005-09-28 | S1 | 1120h | 1120h |  | Alcatel-Lucent | andy.bennett@alcatel-lucent.com | Rel-7 | Alain | WLAN |  | 22.101 |  |  |
| 7227 | 2287.3 | Stage 2 for Voice Call Continuity between CS and IMS (incl. I-WLAN) |  | 264d? | 2005-09-06 A | 2006-09-08 A | 100% | 2005-09-06 | 2006-09-08 | 264d? | finish no earlier than 2006-09-08 | S2 | 2112h | 2112h |  | Alcatel-Lucent | andy.bennett@alcatel-lucent.com | Rel-7 | Maurice | WLAN |  | 23.206 |  |  |
| 7228 | 2287.4 | SA5 Charging for Voice Call Continuity between CS and IMS (incl. I-WLAN) |  | 325d? | 2006-03-17 A | 2007-06-14 A | 100% | 2006-03-17 | 2007-06-14 | 325d? | finish no earlier than 2007-06-14 | S5 | 2600h | 2600h | VCC-CH | Orange | alain.bibas@orange-ft.com | Rel-7 | Mirko | WLAN | VCC-CH | 32.250; 32.260 |  |  |
| 7229 | 2287.5 | **Stage 3 for Voice Call Continuity between CS and IMS (incl. I-WLAN)** |  | 358d? | 2006-02-01 A | 2007-06-15 A | 100% | 2006-02-01 | 2007-06-15 | 358d? |  | C1; C4 | 10160h | 10160h |  | Alcatel-Lucent | Keith Drage (drage@alcatel-lucent.com) | Rel-7 | Frederic | WLAN |  |  |  |  |
| 7230 | 2287.5.1 | CT1 aspects of Stage 3 for Voice Call Continuity between CS and IMS (incl. I-WLAN) |  | 358d? | 2006-02-01 A | 2007-06-15 A | 100% | 2006-02-01 | 2007-06-15 | 358d? | finish no earlier than 2007-06-15 | C1 | 2864h | 2864h |  | Alcatel-Lucent | Keith Drage (drage@alcatel-lucent.com) | Rel-7 | Frederic | WLAN |  | 24.206; 24.216 |  |  |
| 7231 | 2287.5.2 | CT4 aspects of Stage 3 for Voice Call Continuity between CS and IMS (incl. I-WLAN) |  | 196d? | 2006-06-09 A | 2007-03-09 A | 100% | 2006-06-09 | 2007-03-09 | 196d? | start no earlier than 2006-06-09 | C4 | 1568h | 1568h | VCC-St3-c4 | Alcatel-Lucent | Keith Drage (drage@alcatel-lucent.com) | Rel-7 | Kimmo | WLAN | VCC-St3-c4 | 23.003 |  |  |
| 7232 | 2287.5.3 | Deleted - CT3 aspects of Stage 3 for Voice Call Continuity between CS and IMS (incl. I-WLAN) | milestone | 0d? | 2006-11-02 A | 2006-11-02 A | 100% | 2006-11-02 | 2006-11-02 | 0d? | finish no earlier than 2006-11-02 | C3 |  |  |  | Alcatel-Lucent | Keith Drage (drage@alcatel-lucent.com) | Rel-7 | Adrian | WLAN |  | 29.163 | CP-33 |  |
| 7233 | 2288 | **One Tunnel solution for optimization of Packet Data Traffic** |  | 418d? | 2006-03-27 A | 2007-10-31 A | 100% | 2006-03-27 | 2007-10-31 | 418d? |  | S2 | 7048h | 7048h | OPTUNEL | Nokia | antti.j.pasanen@nokia.com | Rel-7 | Maurice |  | OPTUNEL |  |  |  |
| 7234 | 2288.1 | Deleted - Study on Stage 2 for One Tunnel solution |  | 125d? | 2006-03-27 A | 2006-09-15 A | 100% | 2006-03-27 | 2006-09-15 | 125d? | finish no earlier than 2005-09-12 | S2 | 1000h | 1000h | OPTUNEL-Study | Nokia | antti.j.pasanen@nokia.com | Rel-7 | Maurice |  | OPTUNEL-Study | 23.809 | SP-34 |  |
| 7235 | 2288.2 | One Tunnel Deployment Guideline |  | 268d? | 2006-10-23 A | 2007-10-31 A | 100% | 2006-10-23 | 2007-10-31 | 268d? | finish no earlier than 2007-10-31 | S2 | 2144h | 2144h | OPTUNEL-Guide | Huawei | lan.liu@huawei.com | Rel-7 | Maurice |  | OPTUNEL-Guide | 23.919 |  | 34 |
| 7236 | 2288.3 | Stage 2 specification for One Tunnel solution |  | 70d? | 2006-09-11 A | 2006-12-15 A | 100% | 2006-09-11 | 2006-12-15 | 70d? | finish no earlier than 2006-12-15 | S2 | 560h | 560h | OPTUNEL-Stage2 | Nokia | antti.j.pasanen@nokia.com | Rel-7 | Maurice |  | OPTUNEL-Stage2 | 23.060 |  |  |
| 7237 | 2289 | **CSI Terminating Session handling** |  | 267d? | 2006-06-08 A | 2007-06-15 A | 100% | 2006-06-08 | 2007-06-15 | 267d? |  | S2; C1 | 6864h | 6864h | CSItermS | Samsung | Osok Song | Rel-7 | Maurice |  | CSItermS |  |  |  |
| 7238 | 2289.1 | Stage 2 of CStermS |  | 192d? | 2006-06-08 A | 2007-03-02 A | 100% | 2006-06-08 | 2007-03-02 | 192d? | start no earlier than 2006-06-08 | S2 | 1536h | 1536h |  | Samsung | Osok Song | Rel-7 | Maurice |  |  | 23.279 |  | 34 |
| 7239 | 2289.2 | Stage 3 of CStermS |  | 132d? | 2006-12-14 A | 2007-06-15 A | 100% | 2006-12-14 | 2007-06-15 | 132d? | finish no earlier than 2007-06-15 | C1 | 1056h | 1056h |  | Samsung | chenho.chin@samsung.com | Rel-7 | Frederic |  |  | 24.229; 24.279 |  | 34 |
| 7240 | 2289.3 | Deleted - duplicated with UID 340015 -Stage 3 CSI Terminating Session handling | milestone | 0d? | 2007-03-09 A | 2007-03-09 A | 100% | 2007-03-09 | 2007-03-09 | 0d? | start no earlier than 2007-03-09 | C1 |  |  |  | Samsung | chenho.chin@samsung.com | Rel-7 | Frederic |  |  | 24.229; 24.179; 24.279 | CP-34 | 34 |
| 7241 | 2290 | Liberty Alliance and 3GPP Security Interworking |  | 451d? | 2005-03-10 A | 2006-11-30 A | 100% | 2005-03-10 | 2006-11-30 | 451d? | finish no earlier than 2006-11-30 | S3 | 3608h | 3608h | LibSec | Nokia | Silke.Holtmanns@nokia.com | Rel-7 | Mirko |  | LibSec | 33.980 |  |  |
| 7242 | 2291 | Trust Requirements for Open Platforms in 3GPP |  | 499d? | 2005-01-03 A | 2006-11-30 A | 100% | 2005-01-03 | 2006-11-30 | 499d? | finish no earlier than 2006-11-30 | S3 | 3992h | 3992h | TrustOP | Nokia | Silke.Holtmanns@nokia.com | Rel-7 | Mirko |  | TrustOP | 33.905 |  |  |
| 7243 | 2292 | Development of UEA2 and UIA2 |  | 268d? | 2004-12-01 A | 2005-12-09 A | 100% | 2004-12-01 | 2005-12-09 | 268d? | finish no earlier than 2005-12-09 | S3 | 2144h | 2144h | AlgUEA2 | TeliaSonera | per.christoffersson@teliasonera.com | Rel-7 | Mirko |  | AlgUEA2 | 35.919; 35.215; 35.216; 35.217; 35.218 |  |  |
| 7244 | 2293 | Lawful Interception in the 3GPP Rel-7 architecture |  | 118d? | 2005-06-28 A | 2005-12-08 A | 100% | 2005-06-28 | 2005-12-08 | 118d? | start no earlier than 2005-06-28 | S3 | 944h | 944h | LI-7A | BMWI | berthold.wilhelm@regtp.de | Rel-7 | Mirko |  | LI-7A | 33.106; 33.107; 33.108 |  |  |
| 7245 | 2294 | Key establishment between a UICC and a terminal |  | 201.45d? | 2005-12-07 A | 2006-09-28 A | 100% | 2005-12-07 | 2006-09-28 | 201.45d? | finish no earlier than 2006-09-28 | S3 | 1611.6h | 1611.6h | KeyEstUTerm | Gemalto | mireille.pauliac@gemplus.com | Rel-7 | Mirko |  | KeyEstUTerm | 33.110 |  |  |
| 7246 | 2295 | NDS Authentication Framework Extension for Transport Layer Security |  | 50d? | 2006-09-28 A | 2006-12-06 A | 100% | 2006-09-28 | 2006-12-06 | 50d? | finish no earlier than 2006-09-28 | S3 | 400h | 400h | NDSAFTLS | Nokia | tiina.s.koskinen@nokia.com | Rel-7 | Mirko |  | NDSAFTLS | 33.310 |  |  |
| 7247 | 2296 | **Security enhancements** |  | 319d? | 2005-09-12 A | 2006-11-30 A | 100% | 2005-09-12 | 2006-11-30 | 319d? |  | S3; C1; C4 | 16376h | 16376h | SEC7 |  |  | Rel-7 | Mirko |  | SEC7 |  |  |  |
| 7248 | 2296.1 | HTTPS connection between a UICC and a NAF |  | 1d? | 2005-09-12 A | 2005-09-12 A | 100% | 2005-09-12 | 2005-09-12 | 1d? | start no earlier than 2005-09-12 | S3; C1 | 16h | 16h | SEC7-HSUN | Gemalto | JSeif@axalto.com, mireille.pauliac@gemplus.com | Rel-7 | Mirko |  | SEC7-HSUN | 33.918; 33.222; 24.109 |  |  |
| 7249 | 2296.2 | 2G GBA: 2G SIM usage in 3GPP GAA framework |  | 61d? | 2005-09-12 A | 2005-12-05 A | 100% | 2005-09-12 | 2005-12-05 | 61d? | finish no earlier than 2005-12-05 | S3 | 488h | 488h | SEC7-2GGBA | Nokia | Silke.Holtmanns@nokia.com | Rel-7 | Mirko |  | SEC7-2GGBA | 33.920; 33.220 |  |  |
| 7250 | 2296.3 | Generic Authentication Architecture usage extensions and optimizations |  | 319d? | 2005-09-12 A | 2006-11-30 A | 100% | 2005-09-12 | 2006-11-30 | 319d? | finish no earlier than 2006-11-30 | S3 | 2552h | 2552h | SEC7-GAA2 | Nokia | Silke.Holtmanns@nokia.com | Rel-7 | Mirko |  | SEC7-GAA2 | 33.220; 29.109; 24.109; (33.223 goes to R8) |  |  |

Notes:
- 7224: WID approved SP#27¦updated SP#28¦updated SP#32
- 7225: -
- 7226: -
- 7227: -
- 7228: 03/2006 SP#31 WID approved
- 7229: -
- 7230: -
- 7231: -
- 7232: -
- 7233: -
- 7234: TR for Info SP-33. SP-34: S2 Report intention to discontinue TR
- 7235: -
- 7236: -
- 7237: Triggered by the abandoned Study UID_32117
- 7238: -
- 7239: CP-34 approved WID. CP-35 updated WID
- 7240: CP-34 approved WID
- 7241: WID approved SP#27.
- 7242: WID approved SP#26.
- 7243: WID approved SP#26, Dependant on Funding Availability.
- 7244: -
- 7245: -
- 7246: TLS profile is moved to Rel-8
- 7247: -
- 7248: -
- 7249: -
- 7250: 33.223 goes to R8

| ID | WBS | Task | Duration | Start | Finish | Complete | Baseline start | Baseline finish | Baseline duration | Constraint | Resources | Work | Actual work | Acronym | WI rapporteur name | WI rapporteur e-mail | Release | MCC resp | Acronym_3GU_Export | Impacted TSs and TRs | PCG approved | TSG approved | TSG stopped |
| --- | --- | --- | --- | --- | --- | --- | --- | --- | --- | --- | --- | --- | --- | --- | --- | --- | --- | --- | --- | --- | --- | --- | --- |
| 7251 | 2296.4 | **SS7 TCAP security Gateway** | 241d? | 2005-09-12 A | 2006-08-14 A | 100% | 2005-09-12 | 2006-08-14 | 241d? |  | S3; C4 | 5664h | 5664h | SEC7-NDS-TCAPsec | Siemens | marc.blommaert.ext@nsn.com | Rel-7 | Mirko | SEC7-NDS-TCAPsec |  |  |  |  |
| 7252 | 2296.4.1 | SA3 aspects of SEC7-NDS-TCAPsec | 130d? | 2005-09-12 A | 2006-03-10 A | 100% | 2005-09-12 | 2006-03-10 | 130d? | finish no earlier than 2006-03-10 | S3 | 1040h | 1040h | SEC7-NDS-TCAPsec-SA3 | Siemens | marc.blommaert.ext@nsn.com | Rel-7 | Mirko | SEC7-NDS-TCAPsec-SA3 | 33.204 |  |  |  |
| 7253 | 2296.4.2 | TCAPsec Gateway | 96d? | 2006-04-03 A | 2006-08-14 A | 100% | 2006-04-03 | 2006-08-14 | 96d? | start no earlier than 2006-04-01 | C4 | 768h | 768h | SEC7-TCAP | Siemens | Ulrich.wiehe@gksag.de | Rel-7 | Kimmo | SEC7-TCAP | 29.204; 29.002 |  |  |  |
| 7254 | 2297 | IMS Stage 3 IETF Protocol Alignment | 589d? | 2004-12-10 A | 2007-03-14 A | 100% | 2004-12-10 | 2007-03-14 | 589d? | finish no earlier than 2007-03-15 | C1 | 4712h | 4712h | IMSProtoc |  |  | Rel-7 | Frederic | IMSProtoc | 24.930 | 36 | 71 |  |
| 7255 | 2298 | **Interoperability between VGCS/VBS and A/Gb flexibility** | 253d? | 2006-03-22 A | 2007-03-09 A | 100% | 2006-03-22 | 2007-03-09 | 253d? |  | C1; C4 | 7344h | 7344h | VGCSFlex | Siemens | robert.zaus@nsn.com | Rel-7 | Frederic | VGCSFlex |  |  |  |  |
| 7256 | 2298.1 | CT1 aspects of VGCSFlex | 159d? | 2006-03-22 A | 2006-10-30 A | 100% | 2006-03-22 | 2006-10-30 | 159d? | finish no earlier than 2006-10-30 | C1 | 1272h | 1272h |  | Siemens | robert.zaus@nsn.com | Rel-7 | Frederic |  | 43.068; 43.069 |  |  |  |
| 7257 | 2298.2 | CT4 aspects of VGCSFlex | 253d? | 2006-03-22 A | 2007-03-09 A | 100% | 2006-03-22 | 2007-03-09 | 253d? | finish no earlier than 2007-03-09 | C4 | 2024h | 2024h | VGCSFlex-c4 | Siemens | robert.zaus@nsn.com | Rel-7 | Kimmo | VGCSFlex-c4 | 29.002 |  |  |  |
| 7258 | 2299 | DIAMETER on the GGSN Gi interface | 586d? | 2004-09-10 A | 2006-12-08 A | 100% | 2004-09-10 | 2006-12-08 | 586d? | finish no earlier than 2006-12-08 | C3 | 4688h | 4688h | DIAMGi | Vodafone | Nico.Gabriele@vodafone.com | Rel-7 | Adrian | DIAMGi | 29.061 |  |  |  |
| 7259 | 2300 | DIAMETER on the PDG Wi interface | 586d? | 2004-09-10 A | 2006-12-08 A | 100% | 2004-09-10 | 2006-12-08 | 586d? | finish no earlier than 2006-12-08 | C3 | 4688h | 4688h | DIAMWi | Vodafone | Nico.Gabriele@vodafone.com | Rel-7 | Adrian | DIAMWi | 29.161 |  |  |  |
| 7260 | 2301 | Interworking between the 3GPP CS domain with BICC or ISUP as signalling protocol and external SIP-I networks | 478d? | 2006-09-22 A | 2008-07-22 A | 100% | 2006-09-22 | 2008-07-22 | 478d? | finish no earlier than 2007-09-14 | C3 | 3824h | 3824h | ExtSIPI | Siemens | Thomas.Belling@nsn.com | Rel-7 | Adrian | ExtSIPI | 29.164 |  |  |  |
| 7261 | 2302 | PDU multiplexing at Nb Interface with IP transport | 427d? | 2006-12-04 A | 2008-07-22 A | 100% | 2006-12-04 | 2008-07-22 | 427d? | start no earlier than 2006-12-04 | C3 | 3416h | 3416h | NbIPMux | Alcatel-Lucent | Jean.Rzeznik@alcatel-lucent.fr | Rel-7 | Adrian | NbIPMux | 29.414 |  | 34 |  |
| 7262 | 2303 | **Mp (MRFC - MRFP) interface** | 345d? | 2006-02-13 A | 2007-06-08 A | 100% | 2006-02-13 | 2007-06-08 | 345d? |  | C4; C1 | 9904h | 9904h | Mp | Ericsson | philip.hodges@ericsson.com | Rel-7 | Kimmo | Mp |  |  |  |  |
| 7263 | 2303.1 | CT1 aspects of Mp | 1d | 2006-02-13 A | 2006-02-13 A | 100% | 2006-02-13 | 2006-02-13 | 1d | finish no earlier than 2006-02-13 | C1 | 8h | 8h |  | Ericsson | philip.hodges@ericsson.com | Rel-7 | Frederic |  | 24.229 |  |  |  |
| 7264 | 2303.2 | Deleted - CT3 aspects of Mp | 1d | 2006-09-22 A | 2006-09-22 A | 100% | 2006-09-22 | 2006-09-22 | 1d | start no earlier than 2006-09-22 | C3 | 8h | 8h |  | Ericsson | philip.hodges@ericsson.com | Rel-7 | Adrian |  | 29.162 |  |  | CP-33 |
| 7265 | 2303.3 | Procedures description | 201d? | 2006-06-02 A | 2007-03-09 A | 100% | 2006-06-02 | 2007-03-09 | 201d? | finish no earlier than 2007-03-09 | C4 | 1608h | 1608h | Mp-PROCc4 | Huawei | Chencheng@huawei.com | Rel-7 | Kimmo | Mp-PROCc4 | 23.333 |  |  |  |
| 7266 | 2303.4 | Stage 3 for Mp (MRFC - MRFP) interface | 345d | 2006-02-13 A | 2007-06-08 A | 100% | 2006-02-13 | 2007-06-08 | 345d | finish no earlier than 2007-06-08 | C4 | 2760h | 2760h | Mp-St3c4 | Ericsson | philip.hodges@ericsson.com | Rel-7 | Kimmo | Mp-St3c4 | 29.333 |  |  |  |
| 7267 | 2304 | Routeing of MT-SMS via the HPLMN | 71d? | 2006-12-01 A | 2007-03-09 A | 100% | 2006-12-01 | 2007-03-09 | 71d? | finish no earlier than 2007-03-09 | C4; C1 | 1136h | 1136h | SMSviaH | Vodafone | Nick.Russell@vodafone.com | Rel-7 | Kimmo | SMSviaH | 23.040; 29.002 |  | 34 |  |
| 7268 | 2305 | Mobile Termination whilst the MS is moving to another MSC | 60d? | 2007-03-09 A | 2007-05-31 A | 100% | 2007-03-09 | 2007-05-31 | 60d? | start no earlier than 2007-03-09 | C4 | 480h | 480h | MTmovMS | Alcatel-Lucent | bruno.landais@alcatel-lucent.fr | Rel-7 | Kimmo | MTmovMS | 23.008; 23.012; 23.018; 23.078; 23.079; 29.002 |  |  |  |
| 7269 | 2306 | ISIM API for Java Card | 620d? | 2005-03-14 A | 2007-07-27 A | 100% | 2005-03-14 | 2007-07-27 | 620d? | finish no earlier than 2007-07-27 | C6 | 4960h | 4960h | APIJAVA | Sun | Sebastian Hans | Rel-7 | Xavier | APIJAVA | 31.103; 102 241 | 38 | 74 |  |
| 7270 | 2307 | Rel-7 (U)SIM API Testing (TS 31.213) | 211d? | 2009-05-30 A | 2010-03-19 A | 100% | 2009-05-30 | 2010-03-19 | 211d? | finish no earlier than 2010-03-12 | C6 | 1688h | 1688h | USIM_API_Test | Sagem Orga | gerrit.hartbrod@sagem-orga.com | Rel-7 | Xavier | USIM_API_Test | 31.213 | 23 | 44 |  |
| 7271 | 2308 | High speed interface between the UICC and the ME | 311d? | 2006-09-22 A | 2007-11-30 A | 100% | 2006-09-22 | 2007-11-30 | 311d? | finish no earlier than 2007-11-30 | C6 | 2488h | 2488h | HSI | Gemalto | jacques.seif@GEMALTO.COM | Rel-7 | Xavier | HSI | 31.101 |  |  |  |
| 7272 | 2309 | Video Codec Performance Requirements | 634d? | 2005-01-03 A | 2007-06-07 A | 100% | 2005-01-03 | 2007-06-07 | 634d? | finish no earlier than 2007-06-07 | S4 | 5072h | 5072h | VICPer | Siemens | juergen.pandel@siemens.com | Rel-7 | Paolo | VICPer | 26.234; 26.235; 26.346; 26.140; 26.902 |  |  |  |
| 7273 | 2310 | Dynamic and Interactive Multimedia Scenes | 583d? | 2005-03-15 A | 2007-06-07 A | 100% | 2005-03-15 | 2007-06-07 | 583d? | finish no earlier than 2007-06-07 | S4 | 4664h | 4664h | DIMS | Streamezzo | gaelle.martin-cocher@streamezzo.com | Rel-7 | Paolo | DIMS | 26.140; 26.142; 26.234; 26.244; 23.346 |  |  |  |
| 7274 | 2311 | 3G-324M Video Telephony Call Setup Times Improvements | 341d? | 2005-06-08 A | 2006-09-27 A | 100% | 2005-06-08 | 2006-09-27 | 341d? | finish no earlier than 2006-09-27 | S4 | 2728h | 2728h | VTCSTI | Vodafone | edward.hall@vodafone.co.uk | Rel-7 | Paolo | VTCSTI | 26.911 |  |  |  |

Notes:
- 7251: -
- 7252: -
- 7253: -
- 7254: TR 24.930: Signalling flows for the session setup in the IM CN subsystem based on Session Initiation Protocol (SIP)
- 7255: Voice Group Call Service
- 7256: -
- 7257: -
- 7258: -
- 7259: -
- 7260: -
- 7261: -
- 7262: -
- 7263: -
- 7264: CP#34: CT3 not involved in Mp interface definition
- 7265: -
- 7266: -
- 7267: WID approved in CP#34
- 7268: -
- 7269: -
- 7270: CP#47 completed. Update of Rel-6 (U)SIM API for Java Card Testing UID_43007 under Rel-6 UICC/USIM enhancements and interworking UID_1800
- 7271: Following ETSI publication of TS 102 600, expected to be completed at CT6 meeting 45
- 7272: -
- 7273: -
- 7274: -

| ID | WBS | Task | Duration | Start | Finish | Complete | Baseline start | Baseline finish | Baseline duration | Constraint | Resources | Work | Actual work | Acronym | WI rapporteur name | WI rapporteur e-mail | Release | MCC resp | Acronym_3GU_Export | TSG stopped |
| --- | --- | --- | --- | --- | --- | --- | --- | --- | --- | --- | --- | --- | --- | --- | --- | --- | --- | --- | --- | --- |
| 7275 | 2312 | **Optimizations for Multimedia Telephony over IMS** | 2d? | 2005-09-28 A | 2005-09-29 A | 100% | 2005-09-28 | 2005-09-28 | 0d? |  | S4 | 32h | 32h | OMTIMS | Ericsson | olle.franceschi@ericsson.com | Rel-7 | Paolo | OMTIMS |  |
| 7276 | 2312.1 | Deleted - Characterisation of Adaptive Jitter Management Performance for VoIP Services | 2d? | 2005-09-28 A | 2005-09-29 A | 100% | 2005-09-28 | 2005-09-28 | 0d? | finish no earlier than 2005-09-29 | S4 | 16h | 16h | OMTIMS-CAJMP | Lucent | dhuo@lucent.com | Rel-7 | Paolo | OMTIMS-CAJMP | SP-35 |
| 7277 | 2313 | End-to-End Multimedia Services Performance Metrics | 382d? | 2005-09-28 A | 2007-03-15 A | 100% | 2005-09-28 | 2007-03-15 | 382d? | finish no earlier than 2007-03-15 | S4 | 3056h | 3056h | E2EMSPM | China Mobile | zhangyanyf@chinamobile.com | Rel-7 | Paolo | E2EMSPM |  |
| 7278 | 2314 | Packet Switched Streaming Enhancements | 261d? | 2006-06-08 A | 2007-06-07 A | 100% | 2006-06-08 | 2007-06-07 | 261d? | finish no earlier than 2007-06-07 | S4 | 2088h | 2088h | PSSe | Ericsson | olle.franceschi@ericsson.com | Rel-7 | Paolo | PSSe |  |
| 7279 | 2315 | **Rel-7 Operations, Administration, Maintenance and Provisioning (OAM&P)** | 466d? | 2005-09-02 A | 2007-06-15 A | 100% | 2005-09-02 | 2007-06-26 | 472.86d? |  | S5 | 82616h | 82616h | OAM7 | Huawei | Christian.Toche@huawei.com | Rel-7 | Mirko | OAM7 |  |
| 7280 | 2315.1 | **Rel-7 Network Infrastructure Management** | 465d? | 2005-09-02 A | 2007-06-14 A | 100% | 2005-09-02 | 2007-06-14 | 465d? |  | S5 | 41800h | 41800h | OAM7-NIM |  |  | Rel-7 | Mirko | OAM7-NIM |  |
| 7281 | 2315.1.1 | Enhance NRM to accommodate NGN (IMS as basis of the Next Generation Network) | 465d? | 2005-09-02 A | 2007-06-14 A | 100% | 2005-09-02 | 2007-06-14 | 465d? | finish no earlier than 2007-06-14 | S5 | 3720h | 3720h |  | Motorola |  | Rel-7 | Mirko |  |  |
| 7282 | 2315.1.2 | Co-operative Element Management interface (CO-OP) (Study + Implementation) | 400d? | 2005-09-02 A | 2007-03-15 A | 100% | 2005-09-02 | 2007-03-15 | 400d? | finish no earlier than 2007-03-15 | S5 | 3200h | 3200h |  | Motorola |  | Rel-7 | Mirko |  |  |
| 7283 | 2315.1.3 | Network Management (NM) Itf-N performance criteria | 465d? | 2005-09-02 A | 2007-06-14 A | 100% | 2005-09-02 | 2007-06-14 | 465d? | finish no earlier than 2007-06-14 | S5 | 3720h | 3720h |  | China Mobile |  | Rel-7 | Mirko |  |  |
| 7284 | 2315.1.4 | Delta synchronization between IRP Manager and IRP Agent (Study + Implementation) | 465d? | 2005-09-02 A | 2007-06-14 A | 100% | 2005-09-02 | 2007-06-14 | 465d? | finish no earlier than 2007-06-14 | S5 | 3720h | 3720h |  | Siemens |  | Rel-7 | Mirko |  |  |
| 7285 | 2315.1.5 | Subscription Management (SuM) IRP Solution Sets | 330d? | 2005-09-02 A | 2006-12-07 A | 100% | 2005-09-02 | 2006-12-07 | 330d? | finish no earlier than 2006-12-07 | S5 | 2640h | 2640h |  | Ericsson |  | Rel-7 | Mirko |  |  |
| 7286 | 2315.1.6 | Integration Reference Point (IRP) Security Management | 400d? | 2005-09-02 A | 2007-03-15 A | 100% | 2005-09-02 | 2007-03-15 | 400d? | finish no earlier than 2007-03-15 | S5 | 3200h | 3200h |  | Huawei | Christian.Toche@huawei.com | Rel-7 | Mirko |  |  |
| 7287 | 2315.1.7 | Partial suspension of Itf-N during maintenance/testing (Study + Implementation) | 465d? | 2005-09-02 A | 2007-06-14 A | 100% | 2005-09-02 | 2007-06-14 | 465d? | finish no earlier than 2007-06-14 | S5 | 3720h | 3720h |  | Siemens |  | Rel-7 | Mirko |  |  |
| 7288 | 2315.1.8 | Deleted - Management of Legacy Equipment | 336d? | 2005-09-02 A | 2006-12-15 A | 100% | 2005-09-02 | 2006-12-15 | 336d? | finish no earlier than 2006-12-15 | S5 | 2688h | 2688h |  | Siemens |  | Rel-7 | Mirko |  | SP-35 |
| 7289 | 2315.1.9 | Deleted - Rules for Vendor Specific Extensions | 400d? | 2005-09-02 A | 2007-03-15 A | 100% | 2005-09-02 | 2007-03-15 | 400d? | finish no earlier than 2007-03-15 | S5 | 3200h | 3200h |  | Siemens |  | Rel-7 | Mirko |  | SP-35 |
| 7290 | 2315.1.10 | Backward and Forward Compatibility of IRP systems | 465d? | 2005-09-02 A | 2007-06-14 A | 100% | 2005-09-02 | 2007-06-14 | 465d? | finish no earlier than 2007-06-14 | S5 | 3720h | 3720h |  | Ericsson |  | Rel-7 | Mirko |  |  |
| 7291 | 2315.1.11 | Repeater Network Resource Model (NRM) definition | 214d? | 2006-02-13 A | 2006-12-07 A | 100% | 2006-02-13 | 2006-12-07 | 214d? | finish no earlier than 2006-12-07 | S5 | 1712h | 1712h |  | China Mobile |  | Rel-7 | Mirko |  |  |
| 7292 | 2315.1.12 | UTRAN radio channel power monitoring | 284d? | 2006-02-13 A | 2007-03-15 A | 100% | 2006-02-13 | 2007-03-15 | 284d? | finish no earlier than 2007-03-15 | S5 | 2272h | 2272h |  | China Mobile |  | Rel-7 | Mirko |  |  |
| 7293 | 2315.1.13 | Notification XML Schema | 71d? | 2006-12-07 A | 2007-03-15 A | 100% | 2006-12-07 | 2007-03-15 | 71d? | finish no earlier than 2007-03-15 | S5 | 568h | 568h |  | Huawei | Christian.Toche@huawei.com | Rel-7 | Mirko |  |  |
| 7294 | 2315.2 | **Rel-7 Performance Management** | 465d? | 2005-09-02 A | 2007-06-14 A | 100% | 2005-09-02 | 2007-06-14 | 465d? |  | S5 | 22992h | 22992h | OAM7-PM |  |  | Rel-7 | Mirko | OAM7-PM |  |
| 7295 | 2315.2.1 | Performance measurements definition for CN CS | 400d? | 2005-09-02 A | 2007-03-15 A | 100% | 2005-09-02 | 2007-03-15 | 400d? | finish no earlier than 2007-03-15 | S5 | 3200h | 3200h |  | China Mobile |  | Rel-7 | Mirko |  |  |
| 7296 | 2315.2.2 | Enhancement UTRAN performance measurements definition | 465d? | 2005-09-02 A | 2007-06-14 A | 100% | 2005-09-02 | 2007-06-14 | 465d? | finish no earlier than 2007-06-14 | S5 | 3720h | 3720h |  | China Mobile |  | Rel-7 | Mirko |  |  |
| 7297 | 2315.2.3 | Add TDD specific counters in Performance measurement | 330d? | 2005-09-02 A | 2006-12-07 A | 100% | 2005-09-02 | 2006-12-07 | 330d? | finish no earlier than 2006-12-15 | S5 | 2640h | 2640h |  | CATT |  | Rel-7 | Mirko |  |  |
| 7298 | 2315.2.4 | ATM bearer network Performance measurements | 400d? | 2005-09-02 A | 2007-03-15 A | 100% | 2005-09-02 | 2007-03-15 | 400d? | finish no earlier than 2007-03-15 | S5 | 3200h | 3200h |  | ZTE |  | Rel-7 | Mirko |  |  |
| 7299 | 2315.2.5 | Performance measurements definition for IMS | 465d? | 2005-09-02 A | 2007-06-14 A | 100% | 2005-09-02 | 2007-06-14 | 465d? | finish no earlier than 2007-06-14 | S5 | 3720h | 3720h |  | China Mobile |  | Rel-7 | Mirko |  |  |
| 7300 | 2315.2.6 | HSDPA performance measurements | 349d? | 2006-02-13 A | 2007-06-14 A | 100% | 2006-02-13 | 2007-06-14 | 349d? | finish no earlier than 2007-06-14 | S5 | 2792h | 2792h |  | China Mobile |  | Rel-7 | Mirko |  |  |

Notes:
- 7275: Aug2015: 99%->100 / Impacted TSs and TRs: 26.235; 26.236
- 7276: SP-35 stopped
- 7277: - / Impacted TSs and TRs: 26.944
- 7278: - / Impacted TSs and TRs: 26.234; 26.244
- 7279: OAM7 is an umbrella Feature also for OAM&P related TEI7 type of changes that are not part of any other dedicated feature/WI / Impacted TSs and TRs: 30.817
- 7280: -
- 7281: - / Impacted TSs and TRs: 32.731/2/3/5; 32.631/2/3/5
- 7282: - / Impacted TSs and TRs: 32.806; 32.814; 32.101
- 7283: - / Impacted TSs and TRs: 32.811
- 7284: - / Impacted TSs and TRs: 32.391/2/3/5
- 7285: - / Impacted TSs and TRs: 32.307/317/607/667/665; 32.101; 32.175
- 7286: - / Impacted TSs and TRs: 32.372/3/5; 32.111.32.30x.32.32x.32.33x.32.34x.32.35x.32.36x.32.41x.32.60x.32.61x.32.66x
- 7287: - / Impacted TSs and TRs: 32.381/2/3/5
- 7288: Request to TSG#35 to STOP the WI / Impacted TSs and TRs: new 32.xxx
- 7289: Request to TSG#35 to STOP the WI / Impacted TSs and TRs: 32.62n; For n = 1 to 5
- 7290: - / Impacted TSs and TRs: 32.154
- 7291: - / Impacted TSs and TRs: 32.721/2/3/5
- 7292: - / Impacted TSs and TRs: 32.405; 32.64n; For n = 1 to 5
- 7293: 12/2006 SP#34 WID approved / Impacted TSs and TRs: New 32.325/345/365/415; CR to 32.335/615/665
- 7294: -
- 7295: - / Impacted TSs and TRs: 32.407; 32.408
- 7296: - / Impacted TSs and TRs: 32.405
- 7297: - / Impacted TSs and TRs: 32.405
- 7298: - / Impacted TSs and TRs: No impact on 32.404; 32.405; 32.406; 32.407
- 7299: - / Impacted TSs and TRs: 32.404.32.409.32.437; 32.632/3/4/5
- 7300: - / Impacted TSs and TRs: 32.405

| ID | WBS | Task | Type | Duration | Start | Finish | Complete | Baseline start | Baseline finish | Baseline duration | Constraint | Resources | Work | Actual work | Acronym | WI rapporteur name | Release | MCC resp | Acronym_3GU_Export | TSG stopped | WI rapporteur e-mail | Status Report |
| --- | --- | --- | --- | --- | --- | --- | --- | --- | --- | --- | --- | --- | --- | --- | --- | --- | --- | --- | --- | --- | --- | --- |
| 7301 | 44.5 | **Rel-7 Trace Management** |  | 466d? | 2005-09-02 A | 2007-06-15 A | 100% | 2005-09-02 | 2007-06-26 | 472.86d? |  | S5 | 14096h | 14096h | OAM7-Trace | Vodafone | Rel-7 | Mirko | OAM7-Trace |  |  |  |
| 7302 | 2315.3.1 | End-to-end Service Level tracing for IMS |  | 350d? | 2005-11-11 A | 2007-03-15 A | 100% | 2005-11-11 | 2007-03-15 | 350d? | finish no earlier than 2007-03-15 | S5 | 2800h | 2800h |  | Vodafone | Rel-7 | Mirko |  | SP-31 |  |  |
| 7303 | 2315.3.2 | Trace record content for UTRAN TDD |  | 330d? | 2005-09-02 A | 2006-12-07 A | 100% | 2005-09-02 | 2006-12-07 | 330d? | finish no earlier than 2006-12-07 | S5 | 2640h | 2640h |  | Nokia | Rel-7 | Mirko |  |  |  |  |
| 7304 | 2315.3.3 | IRP for Subscriber and Equipment Trace Management |  | 465d? | 2005-09-02 A | 2007-06-14 A | 100% | 2005-09-02 | 2007-06-14 | 465d? | finish no earlier than 2007-06-14 | S5 | 3720h | 3720h |  | Nokia | Rel-7 | Mirko |  |  |  |  |
| 7305 | 2315.3.4 | Deleted - SIP enhancements for trace | milestone | 0d? | 2007-06-15 A | 2007-06-15 A | 100% | 2007-06-15 | 2007-06-26 | 0d? | start no earlier than 2007-06-15 | C1 |  |  |  |  | Rel-7 | Frederic |  | CP-32 |  |  |
| 7306 | 2315.3.5 | Deleted - duplicated with UID 35063 - IRP for Subscriber and Equipment Trace Management |  | 336d? | 2005-09-02 A | 2006-12-15 A | 100% | 2005-09-02 | 2006-12-15 | 336d? | finish no earlier than 2006-12-15 | S5 | 2688h | 2688h |  | Nokia | Rel-7 | Mirko |  | SP-33 |  |  |
| 7307 | 2316 | **Rel-7 Charging Management small Enhancements** |  | 279d? | 2006-05-22 A | 2007-06-14 A | 100% | 2006-05-22 | 2007-06-14 | 279d? |  | S5 | 5952h | 5952h | CH7 | Orange | Rel-7 | Mirko | CH7 |  | alain.bibas@orange-ft.com |  |
| 7308 | 2316.1 | Alternate Charged Party (ACP) for IMS |  | 279d? | 2006-05-22 A | 2007-06-14 A | 100% | 2006-05-22 | 2007-06-14 | 279d? | finish no earlier than 2007-06-14 | S5 | 2232h | 2232h | CH7-IMS-ACP | Lucent | Rel-7 | Mirko | CH7-IMS-ACP |  | njmazzarella@alcatel-lucent.com |  |
| 7309 | 2316.2 | Align 3GPP Charging with OMA PoC Enabler Release 2.0 |  | 186d? | 2006-09-28 A | 2007-06-14 A | 100% | 2006-09-28 | 2007-06-14 | 186d? | finish no earlier than 2007-06-14 | S5 | 1488h | 1488h | CH7-PoC | Siemens | Rel-7 | Mirko | CH7-PoC |  | Gerald.Goermer@nsn.com |  |
| 7310 | 8.5 | **Multiple-Input Multiple-Output (MIMO) antennas** |  | 1301d? | 2003-03-14 A | 2008-03-07 A | 100% | 2003-03-14 | 2008-03-07 | 1301d? |  | R1; R5 | 55848h | 55848h | MIMO | Alcatel-Lucent | Rel-7 | Patrick | MIMO |  | hchuang@Alcatel-Lucent.com |  |
| 7311 | 2317.1 | MIMO - Physical layer |  | 915d? | 2003-09-12 A | 2007-03-15 A | 100% | 2003-09-12 | 2007-03-15 | 915d? | finish no earlier than 2007-03-15 | R1 | 7320h | 7320h | MIMO-Phys | Alcatel-Lucent | Rel-7 | Patrick | MIMO-Phys |  | hchuang@Alcatel-Lucent.com | RP-070037 |
| 7312 | 2317.2 | MIMO - Layer 2,3 aspects |  | 915d? | 2003-09-12 A | 2007-03-15 A | 100% | 2003-09-12 | 2007-03-15 | 915d? | finish no earlier than 2007-03-15 | R2 | 7320h | 7320h | MIMO-L23 | Alcatel-Lucent | Rel-7 | Yong-Jun | MIMO-L23 |  | hchuang@Alcatel-Lucent.com | RP-070037 |
| 7313 | 2317.3 | MIMO - Iub/Iur Protocol Aspects |  | 1045d? | 2003-03-14 A | 2007-03-15 A | 100% | 2003-03-14 | 2007-03-15 | 1045d? | finish no earlier than 2007-03-15 | R3 | 8360h | 8360h | MIMO-IurIub | Alcatel-Lucent | Rel-7 | Juha | MIMO-IurIub |  | hchuang@Alcatel-Lucent.com | RP-070037 |
| 7314 | 2317.4 | MIMO - RF Radio Transmission/Reception, System Performance Requirements and Conformance Testing |  | 982d? | 2003-12-12 A | 2007-09-17 A | 100% | 2003-12-12 | 2007-09-17 | 982d? | finish no earlier than 2007-09-17 | R4 | 7856h | 7856h | MIMO-RF | Alcatel-Lucent | Rel-7 | Issam | MIMO-RF |  | ngm@Alcatel-Lucent.com | RP-070531 |
| 7315 | 2317.5 | **UE Conformance Testing for Multiple Input Multiple Output antennas (MIMO)** |  | 261d? | 2007-03-09 A | 2008-03-07 A | 100% | 2007-03-09 | 2008-03-07 | 261d? |  | R5 | 4176h | 4176h | MIMO-UEConTest | Qualcomm | Rel-7 | Ingbert | MIMO-UEConTest |  | svora@qualcomm.com |  |
| 7316 | 2317.5.1 | Conformance Test Aspects – Multiple Input Multiple Output Antennas (MIMO) for FDD |  | 261d? | 2007-03-09 A | 2008-03-07 A | 100% | 2007-03-09 | 2008-03-07 | 261d? | finish no earlier than 2008-03-07 | R5 | 2088h | 2088h | MIMO-UEConTest_FDD | Qualcomm | Rel-7 | Ingbert | MIMO-UEConTest_FDD |  | svora@qualcomm.com |  |
| 7317 | 2318 | **Rel-7 Improvements of the Radio Interface** |  | 709d? | 2004-09-15 A | 2007-06-04 A | 100% | 2004-09-15 | 2007-06-04 | 709d? |  | RP; GP | 40520h | 40520h |  |  | Rel-7 | Issam |  |  |  |  |
| 7318 | 2318.1 | Extended UMTS 1.7/2.1 GHz |  | 198d? | 2006-03-15 A | 2006-12-15 A | 100% | 2006-03-15 | 2006-12-15 | 198d? | finish no earlier than 2006-12-15 | R4 | 1584h | 1584h | RInImp-UMTS1721Ext | Ericsson | Rel-7 | Issam | RInImp-UMTS1721Ext |  | johan.skold@ericsson.com | RP-060681 |
| 7319 | 2318.2 | UMTS 2.6 GHz 7.68 Mcps TDD |  | 67d? | 2006-06-15 A | 2006-09-15 A | 100% | 2006-06-15 | 2006-09-15 | 67d? | finish no earlier than 2006-09-15 | R4 | 536h | 536h | RInImp-UMTS26VHCRTDD | IPWireless | Rel-7 | Issam | RInImp-UMTS26VHCRTDD |  | Shin Horng Wong (shwong@ipwireless.com) | RP-060451 |
| 7320 | 2318.3 | UMTS 2.6 GHz |  | 195d? | 2004-09-15 A | 2005-06-14 A | 100% | 2004-09-15 | 2005-06-14 | 195d? | finish no earlier than 2005-06-14 | R4 | 1560h | 1560h | RInImp-UMTS2600 | Nokia | Rel-7 | Issam | RInImp-UMTS2600 |  | jussi.numminen@nokia.com | RP-050184 |
| 7321 | 2318.4 | UMTS 2.6 GHz TDD |  | 261d? | 2004-12-15 A | 2005-12-14 A | 100% | 2004-12-15 | 2005-12-14 | 261d? | finish no earlier than 2005-12-15 | R4 | 2088h | 2088h | RInImp-UMTS2600TDD | IPWireless | Rel-7 | Issam | RInImp-UMTS2600TDD |  | Shin Horng Wong (shwong@ipwireless.com) | RP-050661 |
| 7322 | 2318.5 | UMTS 900 MHz |  | 261d? | 2004-12-15 A | 2005-12-14 A | 100% | 2004-12-15 | 2005-12-14 | 261d? | finish no earlier than 2005-12-15 | R4 | 2088h | 2088h | RInImp-UMTS900 | Nortel | Rel-7 | Issam | RInImp-UMTS900 |  | Yannick Li (yli@nortelnetworks.com) | RP-050662 |
| 7323 | 2318.6 | UMTS 1700 MHz |  | 197d? | 2005-03-15 A | 2005-12-14 A | 100% | 2005-03-15 | 2005-12-14 | 197d? | finish no earlier than 2005-12-15 | R4 | 1576h | 1576h | RInImp-UMTS1700 | NTT DoCoMo | Rel-7 | Issam | RInImp-UMTS1700 |  | Takehiro Nakamura (nakamurata@nttdocomo.co.jp) | RP-050824 |
| 7324 | 2318.7 | UE Antenna Performance Evaluation Method and Requirements |  | 644d? | 2004-12-15 A | 2007-06-04 A | 100% | 2004-12-15 | 2007-06-04 | 644d? | finish no earlier than 2007-06-04 | R4; GP | 10304h | 10304h | RInImp-UEAnt | TeliaSonera | Rel-7 | Issam | RInImp-UEAnt |  | Christian.Bergljung@TeliaSonera.com | RP-070281 |
| 7325 | 2318.8 | Improved Performance Requirements for HSDPA UE based on Rx Diversity (type 1) & LMMSE equalizer (type 2) | milestone | 0d? | 2005-03-15 A | 2005-03-15 A | 100% | 2005-03-15 | 2005-03-15 | 0d? | finish no earlier than 2005-03-15 | R4 |  |  | RInImp-HSPerf-Type3 | Cingular | Rel-7 | Issam | RInImp-HSPerf-Type3 |  | Marc Grant | RP-060015 |

Notes:
- 7301: -
- 7302: 07/2005: OMA (Stage 1), Stage 2/3 SA5, CT1/3/4 / Impacted TSs and TRs: 32.101; 32.421; 32.422; 32.423
- 7303: - / Impacted TSs and TRs: 32.421; 32.422; 32.423
- 7304: - / Impacted TSs and TRs: 32.441; 32.442; 32.443; 32.445; 32.632; 32.633; 32.635
- 7305: combined with UID 11067
- 7306: - / Impacted TSs and TRs: 32.421.32.422.32.423; 3 new 32.4x1.2.3
- 7307: CH7 is an umbrella Feature also for OAM&P related TEI7 type of changes that are not part of any other dedicated feature/WI / Impacted TSs and TRs: 30.817
- 7308: - / Impacted TSs and TRs: 32.240; 32.260; 32.298; 32.299
- 7309: 09/2006 SP#33 WID approved / Impacted TSs and TRs: 32.240; 32.272; 32.299; 32.298
- 7310: Completed Sep 2007¦SR in RP-070037and RP-070531 / Impacted TSs and TRs: 25.876; 25.996
- 7311: Completed Sep 2007¦SR in RP-070037 / Impacted TSs and TRs: 25.211; 25.212; 25.213; 25.214; 25.215; 25.221
- 7312: Completed Sep 2007¦SR in RP-070037 / Impacted TSs and TRs: 25.876
- 7313: Completed Sep 2007¦SR in RP-070037
- 7314: Completed Sep 2007¦SR in RP-070531
- 7315: BB place holder for a number of RAN5 Tasks
- 7316: - / Impacted TSs and TRs: 34.108; 34.109; 34.121-1; 34.121-2; 34.123-1; 34.123-2; 34.123-3
- 7317: Generic feature
- 7318: RP#34 completed. Introduction of Band X (Extended UMTS 1.7/2.1 GHz) in 25.307 / Impacted TSs and TRs: 25.806; 25.101; 25.104; 25.133; 24.141; 25.331; 25.306; 25.307; 25.423; 25.461; 25.463; 34.121
- 7319: RP#33 completed / Impacted TSs and TRs: 25.102; 25.105; 25.123; 25.113; 25.142; 34.124
- 7320: RP#28 completed / Impacted TSs and TRs: 25.101; 25.104; 25.133; 25.141; 25.331; 25.942; 25.306; 25.307; 34.121
- 7321: RP#30 completed / Impacted TSs and TRs: 25.102; 25.105; 25.113; 25.123; 25.142; 25.331; 25.942; 25.306; 25.307; 34.122; 34.124
- 7322: RP#30 completed / Impacted TSs and TRs: 25.101; 25.104; 25.113; 25.133; 25.141; 25.331; 25.942; 25.306; 25.307; 34.121
- 7323: RP#30 completed / Impacted TSs and TRs: 25.101; 25.104; 25.113; 25.133; 25.141; 25.306; 25.307; 25.331; 34.121
- 7324: RP#36 completed / Impacted TSs and TRs: 25.101; new (25.914; 25.963)
- 7325: RP#27 completed / Impacted TSs and TRs: 25.101

| ID | WBS | Task | Type | Duration | Start | Finish | Complete | Baseline start | Baseline finish | Baseline duration | Constraint | Deadline | Resources | Work | Actual work | Acronym | WI rapporteur name | WI rapporteur e-mail | Release | MCC resp | Acronym_3GU_Export | Status Report | TSG stopped | PCG stopped | Created at |
| --- | --- | --- | --- | --- | --- | --- | --- | --- | --- | --- | --- | --- | --- | --- | --- | --- | --- | --- | --- | --- | --- | --- | --- | --- | --- |
| 7326 | 2318.9 | **Additional minimum UE performance requirement for non-HSDPA channels based on type 1 enhanced receiver (Rx Diversity)** |  | 327d? | 2005-09-15 A | 2006-12-15 A | 100% | 2005-09-15 | 2006-12-15 | 327d? |  |  | R4 | 7344h | 7344h | RInImp-RxDiv | Qualcomm | Serge Willenegger (sergew@qualcomm.com) | Rel-7 | Issam | RInImp-RxDiv |  |  |  |  |
| 7327 | 2318.9.1 | Additional minimum UE performance requirement for DL physical channels in support of DCH/HS-DSCH operation based on type 1 enhanced receiver (RX-Diversity) |  | 195d? | 2005-09-15 A | 2006-06-14 A | 100% | 2005-09-15 | 2006-06-14 | 195d? | finish no earlier than 2006-06-15 |  | R4 | 1560h | 1560h | RInImp-RxDiv-DCH | Cingular | Marc Grant | Rel-7 | Issam | RInImp-RxDiv-DCH | RP-060235 |  |  |  |
| 7328 | 2318.9.2 | Additional minimum UE performance requirement for downlink physical channels in support of MTCH and MCCH operation based on type 1 enhanced receiver (Rx-Diversity) |  | 198d? | 2006-03-15 A | 2006-12-15 A | 100% | 2006-03-15 | 2006-12-15 | 198d? | finish no earlier than 2006-12-15 |  | R4 | 1584h | 1584h | RInImp-RxDiv-MBMS | Qualcomm | Serge Willenegger (sergew@qualcomm.com) | Rel-7 | Issam | RInImp-RxDiv-MBMS | RP-060678 |  |  |  |
| 7329 | 2318.9.3 | Additional minimum UE performance requirement for downlink physical channels in support of E-DCH operation based on type 1 enhanced receiver (Rx-Diversity) |  | 198d? | 2006-03-15 A | 2006-12-15 A | 100% | 2006-03-15 | 2006-12-15 | 198d? | finish no earlier than 2006-12-15 |  | R4 | 1584h | 1584h | RInImp-RxDiv-EDCH | Qualcomm | Serge Willenegger (sergew@qualcomm.com) | Rel-7 | Issam | RInImp-RxDiv-EDCH | RP-060679 |  |  |  |
| 7330 | 2318.10 | Deleted Improved support of gaming over HSDPA/EDCH |  | 262d? | 2005-12-15 A | 2006-12-15 A | 100% | 2005-12-15 | 2006-12-15 | 262d? | finish no earlier than 2006-12-15 |  | R2 | 2096h | 2096h | RInImp-Gaming | Cingular | Don Zelmer (dz1069@att.com) | Rel-7 | Yong-Jun | RInImp-Gaming | RP-060680 | RP-34 |  |  |
| 7331 | 2318.11 | Deleted (not approved at PCG) - UMTS 2.6 GHz FDD DL External | milestone | 0d? | 2005-09-15 A | 2005-09-15 A | 100% | 2005-09-15 | 2005-09-15 | 0d? | finish no earlier than 2005-09-15 |  | R4 |  |  | RInImp-UMTS2600Ext | T-mobile | han.van.bussel@t-mobile.de | Rel-7 | Issam | RInImp-UMTS2600Ext |  | RP-31 | PCG-16 |  |
| 7332 | 2319 | **Rel-7 Improvements of the Radio Interface - UE Conformance Testing** |  | 741d? | 2005-11-11 A | 2008-09-12 A | 100% | 2005-11-11 | 2008-09-12 | 741d? |  |  | R5 | 17568h | 17568h |  |  |  | Rel-7 | Ingbert |  |  |  |  |  |
| 7333 | 16.5.1 | UE Conformance Test for UMTS 2600 MHz |  | 146d | 2005-11-11 A | 2006-06-02 A | 100% | 2005-11-11 | 2006-06-02 | 146d | finish no earlier than 2006-06-02 | 2006-06-02 | R5 | 1168h | 1168h | RInImp-UMTS2600_Test | Nokia | Aleksi.Heino@nokia.com | Rel-7 | Ingbert | RInImp-UMTS2600_Test |  |  |  | Fri 7/11/05 |
| 7334 | 16.5.1 | UE Conformance Test for UMTS 900 MHz (band VIII) |  | 146d | 2005-11-11 A | 2006-06-02 A | 100% | 2005-11-11 | 2006-06-02 | 146d | finish no earlier than 2006-06-02 | 2006-06-02 | R5 | 1168h | 1168h | RInImp-UMTS900_Test | Qualcomm | hanye@qualcomm.com | Rel-7 | Ingbert | RInImp-UMTS900_Test |  |  |  | Fri 11/03/05 |
| 7335 | 2319.3 | Conformance Test Aspects – Improved Performance of HSDPA Receiver type 3 |  | 191d? | 2006-03-10 A | 2006-12-01 A | 100% | 2006-03-10 | 2006-12-01 | 191d? | finish no earlier than 2006-12-01 |  | R5 | 1528h | 1528h | RInImp-HSPerf-Type3_Test | Motorola | carolyn.taylor@motorola.com | Rel-7 | Ingbert | RInImp-HSPerf-Type3_Test |  |  |  |  |
| 7336 | 2319.4 | UE antenna Over The Air (OTA) conformance testing |  | 518d? | 2006-09-20 A | 2008-09-12 A | 100% | 2006-09-20 | 2008-09-12 | 518d? | finish no earlier than 2008-09-12 |  | R5 | 4144h | 4144h | RInImp-UEAnt_Test | Nokia | Aleksi.Heino@nokia.com | Rel-7 | Ingbert | RInImp-UEAnt_Test | RP-080535 |  |  |  |
| 7337 | 2319.5 | UE conformance testing for FDD Inter-Band Operation |  | 131d? | 2006-06-02 A | 2006-12-01 A | 100% | 2006-06-02 | 2006-12-01 | 131d? | finish no earlier than 2006-12-01 |  | R5 | 1048h | 1048h | RInImp-InterBand_Test | NEC, Motorola | Jacob.John@motorola.com | Rel-7 | Ingbert | RInImp-InterBand_Test |  |  |  |  |
| 7338 | 2319.6 | Conformance Test Aspects – Extended UMTS 1.7/2.1 GHz |  | 131d? | 2006-12-01 A | 2007-06-01 A | 100% | 2006-12-01 | 2007-06-01 | 131d? | finish no earlier than 2007-06-01 |  | R5 | 1048h | 1048h | RInImp-UEConTest_UMTS1721Ext | Motorola | carolyn.taylor@motorola.com | Rel-7 | Ingbert | RInImp-UEConTest_UMTS1721Ext | RP-070312 |  |  |  |
| 7339 | 2319.7 | Conformance Test Aspects – Minimum UE performance requirement for downlink physical channels in support of E-DCH operation based on type 1 enhanced receiver (Rx-Diversity) |  | 136d? | 2007-06-01 A | 2007-12-07 A | 100% | 2007-06-01 | 2007-12-07 | 136d? | finish no earlier than 2007-12-07 |  | R5 | 1088h | 1088h | RInImp-UEConTest_RxDivEDCH | Motorola | carolyn.taylor@motorola.com | Rel-7 | Ingbert | RInImp-UEConTest_RxDivEDCH | RP-070810 |  |  |  |
| 7340 | 2319.8 | Conformance Test Aspects – Minimum UE performance requirement for downlink physical channels in support of MTCGH and MCCH operation based on type 1 enhanced receiver (Rx-Diversity) |  | 201d? | 2007-06-01 A | 2008-03-07 A | 100% | 2007-06-01 | 2008-03-07 | 201d? | finish no earlier than 2008-03-07 |  | R5 | 1608h | 1608h | RInImp-UEConTest_RxDivMBMS | Ericsson | leif.mattisson@ericsson.com | Rel-7 | Ingbert | RInImp-UEConTest_RxDivMBMS | RP-080056 |  |  |  |
| 7341 | 2320 | **Rel-7 RAN improvements** |  | 653d? | 2004-12-15 A | 2007-06-15 A | 100% | 2004-12-15 | 2007-06-15 | 653d? |  |  | RP; S5 | 39512h | 39512h |  |  |  | Rel-7 |  |  |  |  |  |  |
| 7342 | 2320.1 | Optimization of channelisation code utilisation for 1.28 Mcps TDD |  | 523d? | 2004-12-15 A | 2006-12-15 A | 100% | 2004-12-15 | 2006-12-15 | 523d? | finish no earlier than 2006-12-15 |  | R1 | 4184h | 4184h | RANimp-RABSE-CodOptLCRTDD | UTStarcom | Ka Leong Lo (kaleong.lo@UTSTAR.COM) | Rel-7 | Patrick | RANimp-RABSE-CodOptLCRTDD | RP-060682 |  |  |  |
| 7343 | 2320.2 | Delay optimization for procedures applicable to CS and PS Connections |  | 394d? | 2005-03-15 A | 2006-09-15 A | 100% | 2005-03-15 | 2006-09-15 | 394d? | finish no earlier than 2006-09-15 |  | R2 | 3152h | 3152h | RANimp-DelayOpt | Nokia | juho.pirskanen@nokia.com | Rel-7 | Yong-Jun | RANimp-DelayOpt | RP-060453 |  |  |  |
| 7344 | 2320.3 | Improved support of IMS Realtime Services using HSDPA/HSUPA |  | 197d? | 2005-03-15 A | 2005-12-14 A | 100% | 2005-03-15 | 2005-12-14 | 197d? | start no earlier than 2005-03-15 |  | R2 | 1576h | 1576h | RANimp-IMSRealTime | Cingular | Don Zelmer (dz1069@att.com) | Rel-7 | Yong-Jun | RANimp-IMSRealTime | RP-050667 |  |  |  |
| 7345 | 2320.4 | UE Performance Requirements for MBMS (TDD) |  | 328d? | 2005-03-15 A | 2006-06-15 A | 100% | 2005-03-15 | 2006-06-15 | 328d? | finish no earlier than 2006-06-15 |  | R4 | 2624h | 2624h | MBMS-RAN-RF-TDD | IPwireless | shwong@ipwireless.com | Rel-7 | Issam | MBMS-RAN-RF-TDD | RP-060477 |  |  |  |
| 7346 | 2320.5 | Continuous connectivity for packet data users |  | 524d? | 2005-03-14 A | 2007-03-15 A | 100% | 2005-03-14 | 2007-03-15 | 524d? | finish no earlier than 2007-03-15 |  | R1 | 4192h | 4192h | RANimp-CPC | Siemens | Joern.Krause@siemens.com | Rel-7 | Patrick | RANimp-CPC | RP-070033 |  |  |  |
| 7347 | 2320.6 | Extended WCDMA Cell Range |  | 198d? | 2006-03-15 A | 2006-12-15 A | 100% | 2006-03-15 | 2006-12-15 | 198d? | finish no earlier than 2006-12-15 |  | R3 | 1584h | 1584h | RANimp-ExtCell | Ericsson | Muhammad Kazmi | Rel-7 | Juha | RANimp-ExtCell | RP-060685 |  |  |  |
| 7348 | 2320.7 | 7.68 Mcps TDD Enhanced Uplink |  | 198d? | 2006-03-15 A | 2006-12-15 A | 100% | 2006-03-15 | 2006-12-15 | 198d? | finish no earlier than 2006-12-15 |  | R1 | 1584h | 1584h | RANimp-VHCRTDD-EDCH | IPwireless | nanderson@ipwireless.com | Rel-7 | Patrick | RANimp-VHCRTDD-EDCH | RP-060684 |  |  |  |
| 7349 | 2320.8 | Enhanced CELL_FACH State in FDD |  | 181d? | 2006-09-25 A | 2007-06-04 A | 100% | 2006-09-25 | 2007-06-04 | 181d? | finish no earlier than 2007-06-04 |  | R2 | 1448h | 1448h | RANimp-EnhState | Nokia | juho.pirskanen@nokia.com | Rel-7 | Yong-Jun | RANimp-EnhState | RP-070286 |  |  |  |
| 7350 | 2320.9 | 64QAM for HSDPA (FDD) |  | 110d? | 2006-12-15 A | 2007-06-04 A | 100% | 2006-12-15 | 2007-06-04 | 110d? | finish no earlier than 2007-06-04 |  | R1 | 880h | 880h | RANimp-64QamDownlink | Ericsson | Johan.Bergman@ericsson.com | Rel-7 | Patrick | RANimp-64QamDownlink | RP-070287 |  |  |  |
| 7351 | 2320.10 | Improved L2 support for high data rates |  | 122d? | 2006-12-15 A | 2007-06-04 A | 100% | 2006-12-15 | 2007-06-04 | 122d? | finish no earlier than 2007-06-04 |  | R2 | 976h | 976h | RANimp-L2DataRates | Ericsson | Janne.Peisa@ericsson.com | Rel-7 | Yong-Jun | RANimp-L2DataRates | RP-070289 |  |  |  |
| 7352 | 2320.11 | Introduction of 16QAM in HSUPA (FDD) |  | 110d? | 2006-12-15 A | 2007-06-04 A | 100% | 2006-12-15 | 2007-06-04 | 110d? | finish no earlier than 2007-06-04 |  | R1 | 880h | 880h | RANimp-16QamUplink | Nokia | Karri.Ranta-aho@nsn.com | Rel-7 | Patrick | RANimp-16QamUplink | RP-070288 |  |  |  |

Notes:
- 7326: - / Impacted TSs and TRs: 25.101
- 7327: RP#32 completed / Impacted TSs and TRs: 25.101
- 7328: RP#34 completed / Impacted TSs and TRs: 25.101
- 7329: RP#34 completed / Impacted TSs and TRs: 25.101
- 7330: RP#34 stopped. SR in RP-060680
- 7331: This item was conditionnaly approved pending decision of PCG#16 who decided not to approve it / Impacted TSs and TRs: 25.101; 25.104; 25.133; 25.141; 25.331; 25.942; 25.306; 25.307; 34.121
- 7332: Linked to Feature UID_20028 (RInImp)
- 7333: RP#32 completed / Impacted TSs and TRs: 34.108; 34.121
- 7334: RP#32 completed / Impacted TSs and TRs: 34.108; 34.121
- 7335: RP#34 completed / Impacted TSs and TRs: 34.121; 34.108
- 7336: RP#41 completed (GERAN aspects might need to be included later) / Impacted TSs and TRs: 34.114
- 7337: RP#34 completed / Impacted TSs and TRs: 34.108; 34.123-1; 34.123-2; 34.123-3
- 7338: RP#36 completed / Impacted TSs and TRs: 34.108; 34.121-1; 34.121-2
- 7339: RP#38 completed
- 7340: RP#39 completed / Impacted TSs and TRs: 34.121-1; 34.121-2
- 7341: Generic feature
- 7342: RP#34 completed
- 7343: RP#33 completed / Impacted TSs and TRs: 25.815; 25.321; 25.322; 25.331
- 7344: RP#30 completed
- 7345: RP#32 completed / Impacted TSs and TRs: 25.102; 25.123
- 7346: RP#35 completed / Impacted TSs and TRs: 25.903; 25.201; 25.211; 25.212; 25.214; 25.308; 25.321; 25.331; 25.423; 25.433; 25.101; 25.133
- 7347: RP#34 completed / Impacted TSs and TRs: 25.133; 25.423; 25.425; 25.433; 25.435; 25.453; 25.331
- 7348: RP#34 completed / Impacted TSs and TRs: 25.201; 25.202; 25.221; 25.222; 25.223; 25.224; 25.225; 25.331; 23.321; 25.306; 25.302; 25.401; 25.420; 25.423; 25.427; 25.433; 25.102; 25.105; 25.142
- 7349: RP#36 completed / Impacted TSs and TRs: 25.308; 25.304; 25.306; 25.321; 25.331; 25.433; 25.435; 25.423; 25.425.
- 7350: RP#36 completed / Impacted TSs and TRs: 25.308; 25.211; 25.212; 25.213; 25.306; 25.331; 25.433; 25.435; 25.423; 25.425; 25.101; 25.104; 25.141
- 7351: RP#36 completed / Impacted TSs and TRs: 25.301; 25.308.25.306; 25.321; 25.322; 25.331; 25.433; 25.435; 25.423; 25.425; 25.999
- 7352: RP#36 completed / Impacted TSs and TRs: 25.319; 25.101; 25.104; 25.133; 25.141; 25.211; 25.212; 25.213; 25.214; 25.306; 25.321; 25.331; 25.423; 25.433

| ID | WBS | Task | Duration | Start | Finish | Complete | Baseline start | Baseline finish | Baseline duration | Constraint | Resources | Work | Actual work | Acronym | WI rapporteur name | WI rapporteur e-mail | Release | MCC resp | Status Report | Acronym_3GU_Export | PCG approved | TSG approved |
| --- | --- | --- | --- | --- | --- | --- | --- | --- | --- | --- | --- | --- | --- | --- | --- | --- | --- | --- | --- | --- | --- | --- |
| 7353 | 2320.12 | **Interface to control Tower Mounted Amplifiers (TMAs)** | 271d? | 2006-06-02 A | 2007-06-15 A | 100% | 2006-06-02 | 2007-06-15 | 271d? |  | R3; S5 | 5984h | 5984h | RANImp-TMA | Vodafone | alexej.kulakov@vodafone.com | Rel-7 | Juha | RP-070140 | RANImp-TMA |  |  |
| 7354 | 2320.12.1 | RAN3 part of Interface to control Tower Mounted Amplifiers (TMAs) | 206d? | 2006-06-02 A | 2007-03-16 A | 100% | 2006-06-02 | 2007-03-16 | 206d? |  | R3 | 840h | 840h |  | Vodafone | alexej.kulakov@vodafone.com | Rel-7 | Juha | RP-070140 |  |  |  |
| 7355 | 2320.12.2 | OAM aspects to Interface to control TMAs | 101d? | 2007-01-26 A | 2007-06-15 A | 100% | 2007-01-26 | 2007-06-15 | 101d? | finish no earlier than 2007-06-15 | S5 | 808h | 808h | RANImp-TMA-OAM | Vodafone | Adrian.Neal@vodafone.com | Rel-7 | Mirko |  | RANImp-TMA-OAM |  |  |
| 7356 | 2321 | **Rel-7 RAN improvements - UE Conformance Testing** | 784d? | 2006-09-20 A | 2009-09-18 A | 100% | 2006-09-20 | 2009-09-18 | 784d? |  | R5 | 25472h | 25472h |  |  |  | Rel-7 | Ingbert |  |  |  |  |
| 7357 | 2321.1 | Conformance Test Aspects - 3.84 Mcps and 7.68 Mcps TDD Enhanced Uplink | 518d? | 2006-09-20 A | 2008-09-12 A | 100% | 2006-09-20 | 2008-09-12 | 518d? | finish no earlier than 2008-09-12 | R5 | 4144h | 4144h | RANimp-UEConTest_EDCHTDH | IPWireless | tspeight@ipwireless.com | Rel-7 | Ingbert | RP-080536 | RANimp-UEConTest_EDCHTDH |  |  |
| 7358 | 2321.2 | Conformance Test Aspects – 64QAM for HSDPA (FDD) | 257d? | 2007-03-09 A | 2008-03-03 A | 100% | 2007-03-09 | 2008-03-03 | 257d? | finish no earlier than 2008-03-03 | R5 | 2056h | 2056h | RANimp-UEConTest_64QamDownlink | Ericsson | leif.mattisson@ericsson.com | Rel-7 | Ingbert | RP-080059 | RANimp-UEConTest_64QamDownlink |  |  |
| 7359 | 2321.3 | Conformance Test Aspects – 16QAM for HSUPA (FDD) | 321d? | 2007-03-09 A | 2008-05-30 A | 100% | 2007-03-09 | 2008-05-30 | 321d? | finish no earlier than 2008-05-30 | R5 | 2568h | 2568h | RANimp-UEConTest_16QamUplink | Motorola | carolyn.taylor@motorola.com | Rel-7 | Ingbert | RP-080281 | RANimp-UEConTest_16QamUplink |  |  |
| 7360 | 2321.4 | Conformance Test Aspects – Improved L2 support for high data rates | 321d? | 2007-03-09 A | 2008-05-30 A | 100% | 2007-03-09 | 2008-05-30 | 321d? | finish no earlier than 2008-05-30 | R5 | 2568h | 2568h | RANimp-UEConTest_L2DataRates | Ericsson | leif.mattisson@ericsson.com | Rel-7 | Ingbert | RP-080256 | RANimp-UEConTest_L2DataRates |  |  |
| 7361 | 2321.5 | Conformance Test Aspects – Continuous connectivity for packet data users | 321d? | 2007-03-09 A | 2008-05-30 A | 100% | 2007-03-09 | 2008-05-30 | 321d? | finish no earlier than 2008-05-30 | R5 | 2568h | 2568h | RANimp-UEConTest_CPC | Nokia | jarkko.hellsten@nokia.com | Rel-7 | Ingbert | RP-080282 | RANimp-UEConTest_CPC |  |  |
| 7362 | 2321.6 | Conformance Test Aspects – Enhanced CELL_FACH state in FDD | 662d? | 2007-03-09 A | 2009-09-18 A | 100% | 2007-03-09 | 2009-09-18 | 662d? | finish no earlier than 2009-09-18 | R5 | 5296h | 5296h | RANimp-UEConTest_EnhancedCellFACHState | Nokia | jarkko.hellsten@nokia.com | Rel-7 | Ingbert | RP-090711 | RANimp-UEConTest_EnhancedCellFACHState |  |  |
| 7363 | 2322 | **7.68 Mcps TDD option** | 783d? | 2004-09-15 A | 2007-09-14 A | 100% | 2004-09-15 | 2007-09-14 | 783d? |  | R1; R2; R3; R4; R5 | 49552h | 49552h | VHCRTDD | IPwireless | Martin Beale (mbeale@ipwireless.com) | Rel-7 | Patrick | RP-060684 | VHCRTDD |  |  |
| 7364 | 2322.1 | VHCRTDD: Stage 2 | 391d? | 2004-09-15 A | 2006-03-15 A | 100% | 2004-09-15 | 2006-03-15 | 391d? | finish no earlier than 2006-03-15 | R1 | 3128h | 3128h | VHCRTDD-Stage2 | IPwireless | Martin Beale (mbeale@ipwireless.com) | Rel-7 | Patrick | RP-060684 | VHCRTDD-Stage2 |  |  |
| 7365 | 2322.2 | VHCRTDD: Physical Layer | 391d? | 2004-09-15 A | 2006-03-15 A | 100% | 2004-09-15 | 2006-03-15 | 391d? | finish no earlier than 2006-03-15 | R1 | 3128h | 3128h | VHCRTDD-Phys | IPwireless | Martin Beale (mbeale@ipwireless.com) | Rel-7 | Patrick | RP-060684 | VHCRTDD-Phys |  |  |
| 7366 | 2322.3 | VHCRTDD: Layer 2 and layer 3 protocol aspects | 391d? | 2004-09-15 A | 2006-03-15 A | 100% | 2004-09-15 | 2006-03-15 | 391d? | finish no earlier than 2006-03-15 | R2 | 3128h | 3128h | VHCRTDD-L23 | IPwireless | drichards@ipwireless.com | Rel-7 | Yong-Jun | RP-060684 | VHCRTDD-L23 |  |  |
| 7367 | 2322.4 | VHCRTDD: UTRAN Iub/Iur Protocol Aspects | 391d? | 2004-09-15 A | 2006-03-15 A | 100% | 2004-09-15 | 2006-03-15 | 391d? | finish no earlier than 2006-03-15 | R3 | 3128h | 3128h | VHCRTDD-IurIub | IPwireless | Peter Legg (plegg@ipwireless.com) | Rel-7 | Juha | RP-060684 | VHCRTDD-IurIub |  |  |
| 7368 | 2322.5 | VHCRTDD: RF Radio Transmission/ Reception, System Performance Requirements and Conformance Testing | 457d? | 2004-09-15 A | 2006-06-15 A | 100% | 2004-09-15 | 2006-06-15 | 457d? | finish no earlier than 2006-06-15 | R4 | 3656h | 3656h | VHCRTDD-RF | IPwireless | Shin Horng Wong (shwong@ipwireless.com) | Rel-7 | Issam | RP-060684 | VHCRTDD-RF |  |  |
| 7369 | 2322.6 | Conformance Test Aspects - 7.68 Mcps TDD | 258d? | 2006-09-20 A | 2007-09-14 A | 100% | 2006-09-20 | 2007-09-14 | 258d? | finish no earlier than 2007-09-10 | R5 | 2064h | 2064h | VHCRTDD-UEConTest | IPWireless | tspeight@ipwireless.com | Rel-7 | Ingbert | RP-070307 | VHCRTDD-UEConTest |  |  |
| 7370 | 2323 | **3.84 Mcps TDD Enhanced Uplink** | 394d? | 2005-03-15 A | 2006-09-15 A | 100% | 2005-03-15 | 2006-09-15 | 394d? |  | RP | 18384h | 18384h | EDCHTDD | IPwireless | nanderson@ipwireless.com | Rel-7 |  | RP-060462 | EDCHTDD |  |  |
| 7371 | 2323.1 | EDCHTDD: Stage 2 | 328d? | 2005-03-15 A | 2006-06-15 A | 100% | 2005-03-15 | 2006-06-15 | 328d? | finish no earlier than 2006-06-15 | R2 | 2624h | 2624h | EDCHTDD-Stage2 | IPwireless | nanderson@ipwireless.com | Rel-7 | Yong-Jun | RP-060462 | EDCHTDD-Stage2 |  |  |
| 7372 | 2323.2 | EDCHTDD: Physical Layer | 394d? | 2005-03-15 A | 2006-09-15 A | 100% | 2005-03-15 | 2006-09-15 | 394d? | finish no earlier than 2006-09-15 | R1 | 3152h | 3152h | EDCHTDD-Phys | IPwireless | nanderson@ipwireless.com | Rel-7 | Patrick | RP-060462 | EDCHTDD-Phys |  |  |
| 7373 | 2323.3 | EDCHTDD: Layer 2 and 3 Protocol Aspects | 394d? | 2005-03-15 A | 2006-09-15 A | 100% | 2005-03-15 | 2006-09-15 | 394d? | finish no earlier than 2006-09-15 | R2 | 3152h | 3152h | EDCHTDD-L23 | IPwireless | drichards@ipwireless.com | Rel-7 | Yong-Jun | RP-060462 | EDCHTDD-L23 |  |  |
| 7374 | 2323.4 | EDCHTDD: UTRAN Iub/Iur Protocol Aspects | 394d? | 2005-03-15 A | 2006-09-15 A | 100% | 2005-03-15 | 2006-09-15 | 394d? | finish no earlier than 2006-09-15 | R3 | 3152h | 3152h | EDCHTDD-IurIub | Interdigital | jim.miller@interdigital.com | Rel-7 | Juha | RP-060462 | EDCHTDD-IurIub |  |  |
| 7375 | 2323.5 | EDCHTDD: RF Radio Transmission/ Reception, System Performance Requirements and Conformance Testing | 394d? | 2005-03-15 A | 2006-09-15 A | 100% | 2005-03-15 | 2006-09-15 | 394d? | finish no earlier than 2006-09-15 | R4 | 3152h | 3152h | EDCHTDD-RF | IPwireless | Shin Horng Wong (shwong@ipwireless.com) | Rel-7 | Issam | RP-060462 | EDCHTDD-RF |  |  |
| 7376 | 2324 | **1.28 Mcps TDD Enhanced Uplink** | 653d? | 2006-03-15 A | 2008-09-12 A | 100% | 2006-03-15 | 2008-09-12 | 653d? |  | R1; R2; R3; R4; R5 | 35656h | 35656h | LCRTDD-EDCH | CATT | Haijing Hu | Rel-7 | Patrick | RP-070296 | LCRTDD-EDCH |  |  |
| 7377 | 2324.1 | 1.28 Mcps TDD Enhanced Uplink: Physical Layer | 262d? | 2006-03-15 A | 2007-03-15 A | 100% | 2006-03-15 | 2007-03-15 | 262d? | finish no earlier than 2007-03-15 | R1 | 2096h | 2096h | LCRTDD-EDCH-Phys | CATT | Ke Wang | Rel-7 | Patrick | RP-070038 | LCRTDD-EDCH-Phys |  |  |
| 7378 | 2324.2 | 1.28 Mcps TDD Enhanced Uplink: Layer 2 and 3 Protocol Aspects | 262d? | 2006-03-15 A | 2007-03-15 A | 100% | 2006-03-15 | 2007-03-15 | 262d? | finish no earlier than 2007-03-15 | R2 | 2096h | 2096h | LCRTDD-EDCH-L23 | CATT | Haiyang Quan | Rel-7 | Yong-Jun | RP-070038 | LCRTDD-EDCH-L23 |  |  |
| 7379 | 2324.3 | 1.28 Mcps TDD Enhanced Uplink: UTRAN Iub/Iur Protocol Aspects | 262d? | 2006-03-15 A | 2007-03-15 A | 100% | 2006-03-15 | 2007-03-15 | 262d? | finish no earlier than 2007-03-15 | R3 | 2096h | 2096h | LCRTDD-EDCH-IubIur | CATT | Yincheng Zhang | Rel-7 | Juha | RP-070038 | LCRTDD-EDCH-IubIur |  |  |
| 7380 | 2324.4 | 1.28 Mcps TDD Enhanced Uplink: RF Radio Transmission/ Reception, System Performance Requirements and Conformance Testing | 328d? | 2006-03-15 A | 2007-06-15 A | 100% | 2006-03-15 | 2007-06-15 | 328d? | finish no earlier than 2007-06-15 | R4 | 2624h | 2624h | LCRTDD-EDCH-RF | CATT | Yuexia Song (songyuexia@catt.cn) | Rel-7 | Issam | RP-070296 | LCRTDD-EDCH-RF |  |  |
| 7381 | 2324.5 | 1.28 Mcps TDD Enhanced Uplink - UE Conformance Testing | 257d? | 2007-09-20 A | 2008-09-12 A | 100% | 2007-09-20 | 2008-09-12 | 257d? | finish no earlier than 2008-09-11 | R5 | 624h | 624h | LCRTDD-EDCH-UEConTest | CATT | chenxiaozhong@datangmobile.cn | Rel-7 | Ingbert | RP-080539 | LCRTDD-EDCH-UEConTest |  |  |
| 7382 | 2325 | Conformance Test Aspects – Multiple Band and Multiple Frequency operation for LCR TDD | 263d? | 2010-09-17 A | 2011-09-16 A | 100% | 2010-09-17 | 2011-09-16 | 263d? | finish no earlier than 2011-12-09 | R5 | 2091.37h | 2091.37h | LCRTDD_MB_MF_UEConTest | CATR | Ms Jun Chen (chenjun@catr.cn) | Rel-7 | Ingbert | RP-110968 | LCRTDD_MB_MF_UEConTest | 25 | 49 |
| 7383 | 2326 | MS Antenna Performance Evaluation Method and Requirements | 731d? | 2005-01-28 A | 2007-11-16 A | 100% | 2005-01-28 | 2007-11-16 | 731d? | finish no earlier than 2007-11-16 | GP | 5848h | 5848h | APEMR | TeliaSonera | Ulf.Tegth@teliasonera.com | Rel-7 | Paolo |  | APEMR |  |  |

Notes:
- 7353: RP#35 completed
- 7354: RP#35 completed
- 7355: SP#36 completed / Impacted TSs and TRs: 32.642; 32.643; 32.645 – Align with RAN 25.466
- 7356: Linked to Feature UID_20029 (RANimp)
- 7357: RP#41 completed / Impacted TSs and TRs: 34.108; 34.122; 34.123-1; 34.123-2; 34.123-3
- 7358: RP#39 completed / Impacted TSs and TRs: 34.108; 34.121-1; 34.121-2; 34.123-1; 34.123-2; 34.123-3
- 7359: RP#40 completed / Impacted TSs and TRs: 34.108; 34.121-1; 34.121-2; 34.123-1; 34.123-2; 34.123-3
- 7360: RP#40 completed / Impacted TSs and TRs: 34.108; 34.123-1; 34.123-2; 34.123-3
- 7361: RP#40 completed / Impacted TSs and TRs: 34.108; 34.121-1; 34.121-2; 34.123-1; 34.123-2; 34.123-3
- 7362: RP#45 completed / Impacted TSs and TRs: 34.108; 34.123-1; 34.123-2; 34.123-3
- 7363: RP#31 completed
- 7364: RP#31 completed / Impacted TSs and TRs: 25.202
- 7365: RP#31 completed / Impacted TSs and TRs: 25.221; 25.222; 25.223; 25.224.25.225
- 7366: RP#31 completed / Impacted TSs and TRs: 25.301; 25.302; 25.305; 25.306; 25.321; 25.331
- 7367: RP#31 completed / Impacted TSs and TRs: 25.401; 25.420; 25.423; 25.425; 25.427; 25.430; 25.433; 25.435
- 7368: RP#32 completed / Impacted TSs and TRs: 25.102; 25.105; 25.123; 25.133; 25.142
- 7369: RP#37 completed / Impacted TSs and TRs: 34.108; 34.122; 34.123-1; 34.123-2; 34.123-3
- 7370: RP#33 completed
- 7371: RP#33 completed
- 7372: RP#33 completed / Impacted TSs and TRs: 25.201; 25.221.25.222; 25.223; 25.224; 25.225
- 7373: RP#33 completed / Impacted TSs and TRs: 25.301; 25.302; 25.306; 25.321; 25.331
- 7374: RP#33 completed / Impacted TSs and TRs: 25.401; 25.420; 25.423; 25.427; 25.430; 25.433; 25.435
- 7375: RP#33 completed / Impacted TSs and TRs: 25.102; 25.105; 25.123; 25.142
- 7376: RP#35 completed
- 7377: RP#35 completed / Impacted TSs and TRs: 25.201; 25.221; 25.222; 25.223; 25.224; 25.225
- 7378: RP#35 completed / Impacted TSs and TRs: 25.301; 25.302; 25.306; 25.321; 25.331
- 7379: RP#35 completed / Impacted TSs and TRs: 25.401; 25.420; 25.423; 25.425; 25.427; 25.430; 25.433; 25.435
- 7380: RP#36 completed / Impacted TSs and TRs: 25.102; 25.105; 25.123; 25.142
- 7381: RP#41 completed / Impacted TSs and TRs: 34.108; 34.122; 34.123-1/2/3
- 7382: RP#53 completed. Core specification was introduced via Rel-7 CR under TEI7 (RP#37 RP-070650) and via 2 Rel-8 work items: RInImp9-UMTS1880TDD and RInImp8-UMTS2300TDD. / Impacted TSs and TRs: UTRA 34.108; 34.123-1; 34.123-2; 34.123-3
- 7383: GP#36 completed for R7 / Impacted TSs and TRs: 25.914; 25.144; 45.005

| ID | WBS | Task | Type | Duration | Start | Finish | Complete | Baseline start | Baseline finish | Baseline duration | Constraint | Resources | Work | Actual work | Acronym | WI rapporteur name | WI rapporteur e-mail | Release | MCC resp | Acronym_3GU_Export | TSG stopped |
| --- | --- | --- | --- | --- | --- | --- | --- | --- | --- | --- | --- | --- | --- | --- | --- | --- | --- | --- | --- | --- | --- |
| 7384 | 2327 | **Lower 700 MHz Inclusion in the GERAN Specifications** |  | 390d? | 2005-01-03 A | 2006-06-30 A | 100% | 2005-01-03 | 2006-06-30 | 390d? |  | GP | 9372h | 9372h | GSM710 | UTC | dcotton@mtview.union-tel.com | Rel-7 | Paolo | GSM710 |  |
| 7385 | 2327.1 | Inclusion of the 698 – 746 MHz band into GERAN core specifications |  | 129d? | 2005-01-03 A | 2005-06-30 A | 100% | 2005-01-03 | 2005-06-30 | 129d? | finish no earlier than 2005-06-30 | G1 | 1032h | 1032h | GSM710-core |  |  | Rel-7 | Paolo | GSM710-core |  |
| 7386 | 2327.2 | **Aspects of GSM710** |  | 217.5d? | 2005-08-31 A | 2006-06-30 A | 100% | 2005-08-31 | 2006-06-30 | 217.5d? |  | G1; G3new | 5220h | 5220h | GSM-710-test |  |  | Rel-7 | Paolo | GSM-710-test |  |
| 7387 | 2327.2.1 | G1 aspects of GSM710 |  | 217.5d? | 2005-08-31 A | 2006-06-30 A | 100% | 2005-08-31 | 2006-06-30 | 217.5d? | finish no earlier than 2006-06-30 | G1 | 1740h | 1740h |  |  |  | Rel-7 | Paolo |  |  |
| 7388 | 2327.2.2 | G3 aspects of GSM710 |  | 217.5d? | 2005-08-31 A | 2006-06-30 A | 100% | 2005-08-31 | 2006-06-30 | 217.5d? | finish no earlier than 2006-06-30 | G3new | 1740h | 1740h |  |  |  | Rel-7 | Ingbert |  |  |
| 7389 | 2328 | **Support of Conversational Services in A/Gb mode via the PS domain** |  | 626d? | 2005-04-08 A | 2007-08-31 A | 100% | 2005-04-08 | 2007-08-31 | 626d? |  | GP | 15442.8h | 15442.8h | SCSAGB | Ericsson | gunnar.hedby@ericsson.com | Rel-7 | Paolo | SCSAGB |  |
| 7390 | 2328.1 | Minimise the transfer delay between the SGSN and the MS |  | 604.95d? | 2005-04-08 A | 2007-08-31 A | 100% | 2005-04-08 | 2007-08-31 | 604.95d? | finish no earlier than 2007-08-31 | GP | 4839.6h | 4839.6h | SCSAGB-MTD | Ericsson | gunnar.hedby@ericsson.com | Rel-7 | Paolo | SCSAGB-MTD |  |
| 7391 | 2328.2 | Definition of radio resource management functionality for Support of Conversational Services in A/Gb mode via the PS domain |  | 626d? | 2005-04-08 A | 2007-08-31 A | 100% | 2005-04-08 | 2007-08-31 | 626d? | finish no earlier than 2007-08-31 | G1 | 5008h | 5008h | SCSAGB-RRM | Ericsson | gunnar.hedby@ericsson.com | Rel-7 | Paolo | SCSAGB-RRM |  |
| 7392 | 2328.3 | Support of Conversational Services in A/Gb mode via the PS domain – RLC Non-Persistent mode |  | 101d? | 2006-06-30 A | 2006-11-17 A | 100% | 2006-06-30 | 2006-11-17 | 101d? | finish no earlier than 2006-11-17 | G2 | 808h | 808h | SCSAGB-RLCNP | Ericsson | gunnar.hedby@ericsson.com | Rel-7 | Gert | SCSAGB-RLCNP |  |
| 7393 | 2328.4 | Deleted- Radio Channel Support | milestone | 0d? | 2006-07-17 A | 2006-07-17 A | 100% | 2006-07-17 | 2006-07-17 | 0d? | start no earlier than 2006-07-17 | G2 |  |  | SCSAGB-RCHS | Ericsson | gunnar.hedby@ericsson.com | Rel-7 | Gert | SCSAGB-RCHS | SP-32 |
| 7394 | 2328.5 | Deleted- Modifications to FLO | milestone | 0d? | 2006-07-17 A | 2006-07-17 A | 100% | 2006-07-17 | 2006-07-17 | 0d? | start no earlier than 2006-07-17 | G2 |  |  | SCSAGB-FLO | Ericsson | gunnar.hedby@ericsson.com | Rel-7 | Gert | SCSAGB-FLO | SP-32 |
| 7395 | 2329 | **Addition of new frequency band to GSM (T-GSM810)** |  | 626d? | 2005-04-08 A | 2007-08-31 A | 100% | 2005-04-08 | 2007-08-31 | 626d? |  | GP | 12112h | 12112h | TGSM810 | Huawei | chende@huawei.com | Rel-7 | Paolo | TGSM810 |  |
| 7396 | 2329.1 | Changes to core specification |  | 106d? | 2005-04-08 A | 2005-09-02 A | 100% | 2005-04-08 | 2005-09-02 | 106d? | finish no earlier than 2005-09-02 | GP | 848h | 848h | TGSM810-Core | Huawei | chende@huawei.com | Rel-7 | Paolo | TGSM810-Core |  |
| 7397 | 2329.2 | Changes to MS testing specification |  | 626d? | 2005-04-08 A | 2007-08-31 A | 100% | 2005-04-08 | 2007-08-31 | 626d? | finish no earlier than 2007-08-31 | G3new | 5008h | 5008h | TGSM810-MStest | Huawei | chende@huawei.com | Rel-7 | Ingbert | TGSM810-MStest |  |
| 7398 | 2329.3 | Changes to BTS testing specification |  | 156d? | 2005-04-08 A | 2005-11-11 A | 100% | 2005-04-08 | 2005-11-11 | 156d? | finish no earlier than 2005-11-11 | G1 | 1248h | 1248h | TGSM810-BTStest | Huawei | chende@huawei.com | Rel-7 | Paolo | TGSM810-BTStest |  |
| 7399 | 2330 | **Handover of dedicated and shared resources while in Dual Transfer Mode** |  | 421d? | 2005-04-08 A | 2006-11-17 A | 100% | 2005-04-08 | 2006-11-17 | 421d? |  | GP | 12672h | 12672h | HODSRDTM | Nokia | rami.vaittinen@nokia.com | Rel-7 | Paolo | HODSRDTM |  |
| 7400 | 2330.1 | GERAN2 part of Handover of dedicated and shared resources while in Dual Transfer Mode |  | 321d? | 2005-04-08 A | 2006-06-30 A | 100% | 2005-04-08 | 2006-06-30 | 321d? | finish no earlier than 2006-06-30 | G2 | 2568h | 2568h | HODSRDTM-G2 | Nokia | rami.vaittinen@nokia.com | Rel-7 | Gert | HODSRDTM-G2 |  |
| 7401 | 2330.2 | Deleted - MS Conformance Testing |  | 421d? | 2005-04-08 A | 2006-11-17 A | 100% | 2005-04-08 | 2006-11-17 | 421d? | finish no earlier than 2006-11-17 | G3new | 3368h | 3368h | HODSRDTM-MStest | Nokia | rami.vaittinen@nokia.com | Rel-7 | Ingbert | HODSRDTM-MStest | GP-32 |
| 7402 | 2330.3 | Deleted - BTS conformance testing |  | 421d? | 2005-04-08 A | 2006-11-17 A | 100% | 2005-04-08 | 2006-11-17 | 421d? | finish no earlier than 2006-11-17 | G1 | 3368h | 3368h | HODSRDTM-BTStest | Nokia | rami.vaittinen@nokia.com | Rel-7 | Paolo | HODSRDTM-BTStest | GP-32 |
| 7403 | 2331 | **Mobile Station Receive Diversity (DARP Phase II)** |  | 526d? | 2005-11-11 A | 2007-11-16 A | 100% | 2005-11-11 | 2007-11-16 | 526d? |  | GP | 16360h | 16360h | MSRD2 | Nokia | kent.pedersen@nokia.com | Rel-7 | Paolo | MSRD2 |  |
| 7404 | 2331.1 | Performance Requirements for Mobile Station Receive Diversity, DARP Phase II |  | 331d? | 2005-11-11 A | 2007-02-16 A | 100% | 2005-11-11 | 2007-02-16 | 331d? | finish no earlier than 2007-02-16 | GP | 2648h | 2648h | MSRD2-PerfReq | Nokia | kent.pedersen@nokia.com | Rel-7 | Paolo | MSRD2-PerfReq |  |
| 7405 | 2331.2 | Capability signalling of Mobile Station Receive Diversity, DARP Phase II |  | 331d? | 2005-11-11 A | 2007-02-16 A | 100% | 2005-11-11 | 2007-02-16 | 331d? | finish no earlier than 2007-02-16 | GP | 2648h | 2648h | MSRD2-CapSig | Nokia | kent.pedersen@nokia.com | Rel-7 | Paolo | MSRD2-CapSig |  |
| 7406 | 2331.3 | Test Scenarios for Mobile Station Receive Diversity, DARP Phase II |  | 331d? | 2005-11-11 A | 2007-02-16 A | 100% | 2005-11-11 | 2007-02-16 | 331d? | finish no earlier than 2007-02-16 | GP | 2648h | 2648h | MSRD2-TestSc | Nokia | kent.pedersen@nokia.com | Rel-7 | Paolo | MSRD2-TestSc |  |
| 7407 | 2331.4 | MS conformance test of DARP Phase II (MSRD) |  | 526d? | 2005-11-11 A | 2007-11-16 A | 100% | 2005-11-11 | 2007-11-16 | 526d? | finish no earlier than 2007-11-16 | GP | 4208h | 4208h | MSRD2-Msconf | Nokia | kent.pedersen@nokia.com | Rel-7 | Ingbert | MSRD2-Msconf |  |

Notes:
- 7384: -
- 7385: Completed / Impacted TSs and TRs: 24.008; 43.022; 44.018; 44.118; 45; 001; 45.005;
- 7386: -
- 7387: - / Impacted TSs and TRs: 51.021
- 7388: - / Impacted TSs and TRs: 51.010
- 7389: Originally started Nov. 2003 as GP-030443
- 7390: -
- 7391: -
- 7392: - / Impacted TSs and TRs: 43.955; 43.064; 44.060; 45.001; 45.002; 45.003; 45.005; 45.010; 51.010; 51.021
- 7393: -
- 7394: -
- 7395: - / Impacted TSs and TRs: 45.005; 45.050; 24.008; 45.008; 45.001; 43.022; 43.030; 44.018; 44.060; 51.010-1; 51.021
- 7396: - / Impacted TSs and TRs: 45.005; 45.050; 24.008; 45.008; 45.001; 43.022; 43.030; 44.018; 44.060
- 7397: - / Impacted TSs and TRs: 51010-1
- 7398: - / Impacted TSs and TRs: 51021
- 7399: GP#30 completed. Started at GP#24
- 7400: GP#30 completed / Impacted TSs and TRs: 43.055; 44.018; 44.060
- 7401: Stopped, no work done. 12/2008 Marked as stopped ("deleted") / Impacted TSs and TRs: 51-010
- 7402: Stopped, no work done. 12/2008 Marked as stopped ("deleted") / Impacted TSs and TRs: 51.026
- 7403: GP#36 completed
- 7404: GP#33 completed / Impacted TSs and TRs: 45.005
- 7405: GP#33 completed / Impacted TSs and TRs: 24.008
- 7406: GP#33 completed / Impacted TSs and TRs: 45.005
- 7407: GP#36 completed / Impacted TSs and TRs: 51.010

| ID | WBS | Task | Type | Duration | Start | Finish | Complete | Baseline start | Baseline finish | Baseline duration | Constraint | Resources | Work | Actual work | Acronym | WI rapporteur name | WI rapporteur e-mail | Release | MCC resp | Acronym_3GU_Export | TSG stopped |
| --- | --- | --- | --- | --- | --- | --- | --- | --- | --- | --- | --- | --- | --- | --- | --- | --- | --- | --- | --- | --- | --- |
| 7408 | 2332 | **Downlink Dual Carrier** |  | 947d? | 2006-01-20 A | 2009-09-04 A | 100% | 2006-01-20 | 2009-09-04 | 947d? |  | GP | 15446.6h | 15446.6h | GDCDL | Nokia Siemens Networks | leonardo.provvedi@roke.co.uk | Rel-7 | Paolo | GDCDL |  |
| 7409 | 2332.1 | Downlink Dual Carrier Stage 2 |  | 116d? | 2006-01-20 A | 2006-06-30 A | 100% | 2006-01-20 | 2006-06-30 | 116d? | finish no earlier than 2006-06-30 | G1 | 928h | 928h | GDCDL-Stage2 | Nokia Siemens Networks | leonardo.provvedi@roke.co.uk | Rel-7 | Paolo | GDCDL-Stage2 |  |
| 7410 | 2332.2 | Downlink Dual Carrier Stage 3 |  | 421d? | 2006-01-20 A | 2007-08-31 A | 100% | 2006-01-20 | 2007-08-31 | 421d? | finish no earlier than 2007-08-31 | G1 | 3368h | 3368h | GDCDL-Stage3 | Nokia Siemens Networks | leonardo.provvedi@roke.co.uk | Rel-7 | Paolo | GDCDL-Stage3 |  |
| 7411 | 2332.3 | Downlink Dual Carrier – MS Conformance Test |  | 446.82d? | 2006-01-20 A | 2009-09-04 A | 100% | 2006-01-20 | 2009-09-04 | 446.82d? | finish no earlier than 2009-09-04 | G3new | 3574.6h | 3574.6h | GDCDL-MStest | Nokia Siemens Networks | leonardo.provvedi@roke.co.uk | Rel-7 | Ingbert | GDCDL-MStest |  |
| 7412 | 2333 | Support of SIGTRAN in GERAN |  | 116d? | 2006-01-20 A | 2006-06-30 A | 100% | 2006-01-20 | 2006-06-30 | 116d? | finish no earlier than 2006-06-30 | GP | 928h | 928h | GSIGT | Ericsson | peter.ostrup@ericsson.com | Rel-7 | Ingbert | GSIGT |  |
| 7413 | 2334 | **Latency Reductions** |  | 306d? | 2006-06-30 A | 2007-08-31 A | 100% | 2006-06-30 | 2007-08-31 | 306d? |  | GP | 7344h | 7344h | LATRED | Ericsson | Hakan.Persson@Ericsson.com | Rel-7 | Paolo | LATRED |  |
| 7414 | 2334.1 | Improved Ack/Nack reporting |  | 306d? | 2006-06-30 A | 2007-08-31 A | 100% | 2006-06-30 | 2007-08-31 | 306d? | finish no earlier than 2007-08-31 | G2 | 2448h | 2448h | LATRED-ACKNAR | Ericsson | Hakan.Persson@Ericsson.com | Rel-7 | Gert | LATRED-ACKNAR |  |
| 7415 | 2334.2 | Reduced TTI |  | 306d? | 2006-06-30 A | 2007-08-31 A | 100% | 2006-06-30 | 2007-08-31 | 306d? | finish no earlier than 2007-08-31 | G2 | 2448h | 2448h | LATRED-REDTTI | Ericsson | Hakan.Persson@Ericsson.com | Rel-7 | Gert | LATRED-REDTTI |  |
| 7416 | 2335 | PS Handover between GERAN/UTRAN mode and GAN Mode |  | 166d? | 2006-06-30 A | 2007-02-16 A | 100% | 2006-06-30 | 2007-02-16 | 166d? | finish no earlier than 2007-02-16 | G2 | 1328h | 1328h | GUGAN | Ericsson | John.Diachina@Ericsson.com | Rel-7 | Gert | GUGAN |  |
| 7417 | 2336 | **Higher Uplink performance for GERAN Evolution** |  | 1227d? | 2006-09-08 A | 2011-05-20 A | 100% | 2006-09-08 | 2011-05-20 | 1227d? |  | GP | 37184h | 37184h | HUGE | Nokia Siemens Networks, Ericsson | eddie.riddington@nokia.com, stefan.g.eriksson@ericsson.com | Rel-7 | Paolo | HUGE |  |
| 7418 | 2336.1 | Stage 2 for HUGE |  | 261d? | 2006-09-08 A | 2007-09-07 A | 100% | 2006-09-08 | 2007-09-07 | 261d? | finish no earlier than 2007-09-07 | G1 | 2088h | 2088h | HUGE-Stage2 | Nokia Siemens Networks, Ericsson | eddie.riddington@nokia.com, stefan.g.eriksson@ericsson.com | Rel-7 | Paolo | HUGE-Stage2 |  |
| 7419 | 2336.2 | Layer 1 Support for HUGE |  | 381d? | 2006-09-08 A | 2008-02-22 A | 100% | 2006-09-08 | 2008-02-22 | 381d? | finish no earlier than 2008-02-22 | G1 | 3048h | 3048h | HUGE-Layer1 | Nokia Siemens Networks, Ericsson | eddie.riddington@nokia.com, stefan.g.eriksson@ericsson.com | Rel-7 | Paolo | HUGE-Layer1 |  |
| 7420 | 2336.3 | Layer 2/3 Support for HUGE |  | 256d? | 2006-09-08 A | 2007-08-31 A | 100% | 2006-09-08 | 2007-08-31 | 256d? | finish no earlier than 2007-08-31 | G2 | 2048h | 2048h | HUGE-Layer23 | Nokia Siemens Networks, Ericsson | eddie.riddington@nokia.com, stefan.g.eriksson@ericsson.com | Rel-7 | Gert | HUGE-Layer23 |  |
| 7421 | 2336.4 | Performance requirements for HUGE |  | 516d? | 2006-09-08 A | 2008-08-29 A | 100% | 2006-09-08 | 2008-08-29 | 516d? | finish no earlier than 2008-08-29 | G1 | 4128h | 4128h | HUGE-Perfreq | Nokia Siemens Networks, Ericsson | eddie.riddington@nokia.com, stefan.g.eriksson@ericsson.com | Rel-7 | Paolo | HUGE-Perfreq |  |
| 7422 | 2336.5 | BTS Conformance Test for HUGE |  | 782d? | 2006-09-08 A | 2009-09-04 A | 100% | 2006-09-08 | 2009-09-04 | 782d? | finish no earlier than 2009-09-04 | G1 | 6248h | 6248h | HUGE-BTStest | Nokia Siemens Networks, Ericsson | eddie.riddington@nokia.com, stefan.g.eriksson@ericsson.com | Rel-7 | Paolo | HUGE-BTStest |  |
| 7423 | 2336.6 | MS Conformance Test for HUGE |  | 1226d? | 2006-09-08 A | 2011-05-20 A | 100% | 2006-09-08 | 2011-05-20 | 1226d? | finish no earlier than 2011-05-20 | G3new | 9808h | 9808h | HUGE-Mstest | Nokia Siemens Networks, Ericsson | eddie.riddington@nokia.com, stefan.g.eriksson@ericsson.com | Rel-7 | Ingbert | HUGE-Mstest |  |
| 7424 | 2337 | **REduced symbol Duration, Higher Order modulation and Turbo coding (RED HOT) for downlink** |  | 1177d? | 2006-11-17 A | 2011-05-20 A | 100% | 2006-11-17 | 2011-05-20 | 1177d? |  | GP | 28808h | 28808h | REDHOT | Ericsson, Nokia Siemens Networks, Marvell | stefan.g.eriksson@ericsson.com | Rel-7 | Paolo | REDHOT |  |
| 7425 | 2337.1 | Stage 2 for REDHOT |  | 206d? | 2006-11-17 A | 2007-08-31 A | 100% | 2006-11-17 | 2007-08-31 | 206d? | finish no earlier than 2007-08-31 | G1 | 1648h | 1648h | REDHOT-Stage2 | Ericsson, Nokia Siemens Networks, Marvell | stefan.g.eriksson@ericsson.com | Rel-7 | Paolo | REDHOT-Stage2 |  |
| 7426 | 2337.2 | Stage 3 for REDHOT |  | 391d? | 2006-11-17 A | 2008-05-16 A | 100% | 2006-11-17 | 2008-05-16 | 391d? | finish no earlier than 2008-05-16 | G1 | 3128h | 3128h | REDHOT-Stage3 | Ericsson, Nokia Siemens Networks, Marvell | stefan.g.eriksson@ericsson.com | Rel-7 | Paolo | REDHOT-Stage3 |  |
| 7427 | 2337.3 | BTS Conformance Tests for REDHOT |  | 651d? | 2006-11-17 A | 2009-05-15 A | 100% | 2006-11-17 | 2009-05-15 | 651d? | finish no earlier than 2009-05-15 | G1 | 5208h | 5208h | REDHOT-BTStest | Ericsson, Nokia Siemens Networks, Marvell | stefan.g.eriksson@ericsson.com | Rel-7 | Paolo | REDHOT-BTStest |  |
| 7428 | 2337.4 | MS Conformance Tests for REDHOT |  | 1176d? | 2006-11-17 A | 2011-05-20 A | 100% | 2006-11-17 | 2011-05-20 | 1176d? | finish no earlier than 2011-05-20 | G3new | 9408h | 9408h | REDHOT-Mstest | Ericsson, Nokia Siemens Networks, Marvell | stefan.g.eriksson@ericsson.com | Rel-7 | Ingbert | REDHOT-Mstest |  |
| 7429 | 2338 | (Small) Technical Enhancements and Improvements for Rel-7 | milestone | 0d? | 2007-03-26 A | 2007-03-26 A | 100% | 2007-03-26 | 2007-03-26 | 0d? | start no earlier than 2007-03-26 | SP; CP; RP; GP |  |  | TEI7 |  |  | Rel-7 | All | TEI7 |  |
| 7430 | 2339 | Test - (Small) Technical Enhancements and Improvements for Rel-7 |  | 389d? | 2006-06-02 A | 2007-11-28 A | 100% | 2006-06-02 | 2007-11-28 | 389d? | finish no earlier than 2010-06-04 | R5 | 3112h | 3112h | TEI7_Test |  |  | Rel-7 | Ingbert | TEI7_Test |  |
| 7431 | 2340 | **Deleted - PS domain and IMS support for IMS Emergency sessions** |  | 0d? | 2006-06-23 A | 2006-06-23 A | 100% | 2006-06-23 | 2006-09-21 | 63.69d? |  | S2 |  |  | IMS-EMER | Nokia | curt.c.wong@nokia.com | Rel-7 | Maurice | IMS-EMER | SP-30 |
| 7432 | 2340.1 | Deleted - IMS aspects to support IMS Emergency sessions | milestone | 0d? | 2006-06-23 A | 2006-06-23 A | 100% | 2006-06-23 | 2006-09-21 | 0d? | start no earlier than 2006-06-23 | S2 |  |  |  | Nokia | curt.c.wong@nokia.com | Rel-7 | Maurice |  | SP-30 |
| 7433 | 2340.2 | Deleted - PS domain aspects to support IMS Emergency sessions | milestone | 0d? | 2006-06-23 A | 2006-06-23 A | 100% | 2006-06-23 | 2006-09-21 | 0d? | start no earlier than 2006-06-23 | S2 |  |  |  | Nokia | curt.c.wong@nokia.com | Rel-7 | Maurice |  | SP-30 |

Notes:
- 7408: GP#35 completed
- 7409: GP#30 completed / Impacted TSs and TRs: 43.055; 43.064
- 7410: GP#35 completed / Impacted TSs and TRs: 24.008; 44.018; 44.060; 45.001; 45.002; 45.005; 45.008
- 7411: GP#43 completed / Impacted TSs and TRs: 51.010
- 7412: GP#30 completed / Impacted TSs and TRs: 48.001; 48.006; 43.059; 49.031
- 7413: GP#35 completed / Impacted TSs and TRs: 45.001; 45.002; 45.003; 45.005; 45.010; 43.055; 43.064; 44.060; 51.010-1; 51.021
- 7414: GP#35 completed / Impacted TSs and TRs: 45.001; 45.002; 45.003; 45.005; 45.010; 43.055; 43.064; 44.060; 51.010-1; 51.021
- 7415: GP#35 completed / Impacted TSs and TRs: 45.001; 45.002; 45.003; 45.005; 45.010; 43.055; 43.064; 44.060; 51.010-1; 51.021
- 7416: GP#33 completed / Impacted TSs and TRs: 43.318; 44.318; 43.129; 25.306; 24.008; 44.060; 25.331; 51.010
- 7417: GP#39 completed
- 7418: GP#35 completed / Impacted TSs and TRs: 43.055; 43.064
- 7419: GP#37 completed / Impacted TSs and TRs: 45.001; 45.002; 45.003; 45.004; 45.008
- 7420: GP#35 completed / Impacted TSs and TRs: 24.008; 44.018; 44.060
- 7421: GP#39 completed / Impacted TSs and TRs: 45.005
- 7422: GP#43 completed / Impacted TSs and TRs: 51.021
- 7423: GP#50 completed / Impacted TSs and TRs: 51.010
- 7424: GP#38 completed
- 7425: GP#35 completed / Impacted TSs and TRs: 43.055; 43.064
- 7426: GP#38 completed / Impacted TSs and TRs: 24.008; 44.018; 44.060; 45.001; 45.002; 45.003; 45.004; 45.005; 45.008
- 7427: GP#42 completed / Impacted TSs and TRs: 51.021
- 7428: GP#50 completed / Impacted TSs and TRs: 51.010
- 7429: -
- 7430: -
- 7431: Approved at SP#29 / Impacted TSs and TRs: 23.867; 23.abc; 23.060; 23.002; 23.271
- 7432: Approved at SP#29 / Impacted TSs and TRs: 23.867; 23.abc; 23.060; 23.002; 23.271
- 7433: Approved at SP#29 / Impacted TSs and TRs: 23.867; 23.abc; 23.060; 23.002; 23.271

| ID | WBS | Task | Type | Duration | Start | Finish | Complete | Remaining | Baseline start | Baseline finish | Baseline duration | Total slack | Constraint | Resources | Work | Actual work | Acronym | Impacted TSs and TRs | Release | MCC resp | TSG stopped | Acronym_3GU_Export | WI rapporteur name | WI rapporteur e-mail | PCG approved | TSG approved | Special Focus Doc |
| --- | --- | --- | --- | --- | --- | --- | --- | --- | --- | --- | --- | --- | --- | --- | --- | --- | --- | --- | --- | --- | --- | --- | --- | --- | --- | --- | --- |
| 7434 | 16.7 | **Deleted - IMS Local services** |  | 0d? | 2006-01-06 A | 2006-01-06 | 99% | 0d? | 2006-01-06 | 2006-01-06 | 0d? | 0d |  | S2 |  |  | IMSLocal | 23.228 | Rel-7 | Maurice | SP-28 | IMSLocal |  |  |  |  |  |
| 7435 | 16.7.1 | Deleted - Stage 2 | milestone | 0d | 2006-01-06 A | 2006-01-06 A | 100% |  | 2006-01-06 | 2006-01-06 | 0d |  | start no earlier than 2006-01-06 | S2 |  |  |  |  | Rel-7 | Maurice | SP-26 |  |  |  |  |  |  |
| 7436 | 2341.2 | Deleted - Stage 3 for IMS Local services | milestone | 0d? | 2006-01-06 A | 2006-01-06 A | 100% |  | 2006-01-06 | 2006-01-06 | 0d? |  | finish no earlier than 2006-01-06 | C1 |  |  |  |  | Rel-7 | Frederic | SP-25 |  | Lucent | Keith Drage (drage@alcatel-lucent.com) |  |  |  |
| 7437 | 2342 | Deleted - IMS Phase 3 | milestone | 0d? | 2006-01-06 A | 2006-01-06 A | 100% |  | 2006-01-06 | 2006-01-06 | 0d? |  | start no earlier than 2006-01-06 | S2 |  |  |  |  | Rel-7 | Maurice | SP-25 |  |  |  |  |  |  |
| 7438 | 2343 | Deleted - Improvements of Radio Interface | milestone | 0d? | 2004-09-15 A | 2004-09-15 A | 100% |  | 2004-09-15 | 2004-09-15 | 0d? |  | start no earlier than 2004-09-15 | RP |  |  |  |  | Rel-7 | Issam | SP-24 |  |  |  | 36 | 70 |  |
| 7439 | 2344 | Deleted: Generic User Profile Phase 2 | milestone | 0d | 2005-08-08 A | 2006-06-30 A | 100% |  | 2005-08-08 | 2006-06-30 | 0d |  |  | C4 |  |  |  |  | Rel-7 | Kimmo | SP-27 |  |  |  |  |  |  |
| 7440 | 30.4 | Deleted - Stage 3 - Common objects | milestone | 0d | 2005-08-08 A | 2005-08-08 A | 100% |  | 2005-08-08 | 2006-06-30 | 0d |  | finish no earlier than 2006-06-30 | C4 |  |  |  | 24.241 | Rel-7 | Kimmo | SP-27 |  |  |  |  |  |  |
| 7441 | 2346 | Release 7 Studies |  | 841d? | 2004-06-28 A | 2007-09-17 A | 100% |  | 2004-06-28 | 2007-09-17 | 841d? |  |  | CP; GP; RP; SP | 26912h | 26912h |  |  | Rel-7 | All |  |  |  |  |  |  |  |
| 7442 | 2347 | Study on Multimedia Telephony Capabilities for IMS |  | 276d? | 2005-07-11 A | 2006-07-31 A | 100% |  | 2005-07-11 | 2006-07-31 | 276d? |  |  | S1 | 2145.6h | 2145.6h | MITE | 22.973 | Rel-7 | Alain |  | MITE | Ericsson | peter.bleckert@ericsson.com |  |  |  |
| 7443 | 2348 | Study on Behaviour of Multi system UEs |  | 384d? | 2004-06-28 A | 2005-12-15 A | 100% |  | 2004-06-28 | 2005-12-15 | 384d? |  | start no earlier than 2004-06-28 | S1 | 3072h | 3072h | BMSU | 22.936 | Rel-7 | Alain |  | BMSU | Qualcomm | dwilliams@qualcomm.com |  |  |  |
| 7444 | 2349 | Study on Combining CS calls and IMS sessions |  | 189d? | 2004-06-28 A | 2005-03-17 A | 100% |  | 2004-06-28 | 2005-03-17 | 189d? |  | start no earlier than 2004-06-28 | S1 | 1512h | 1512h | IRTSD-CS_IMS | 22.979 | Rel-7 | Alain |  | IRTSD-CS_IMS | TeliaSonera | robert.frank@teliasonera.com |  |  |  |
| 7445 | 2350 | Study on All-IP Network |  | 188d? | 2004-06-28 A | 2005-03-16 A | 100% |  | 2004-06-28 | 2005-03-16 | 188d? |  | start no earlier than 2004-06-28 | S1 | 1504h | 1504h | FS_AIPN | 22.978 | Rel-7 | Alain |  | FS_AIPN | NTT DoCoMo | Shin-ichi Isobe (isobes@nttdocomo.co.jp) |  |  |  |
| 7446 | 2351 | Study on Videotelephony teleservice |  | 231d? | 2005-03-01 A | 2006-01-17 A | 100% |  | 2005-03-01 | 2006-01-17 | 231d? |  |  | S1 | 1848h | 1848h | VidTel | 22.903 | Rel-7 | Alain |  | VidTel | T-Mobile | michael.kurz@t-mobile.at |  |  |  |
| 7447 | 2352 | Study on Network Selection Principles |  | 193d? | 2005-03-15 A | 2005-12-08 A | 100% |  | 2005-03-15 | 2005-12-08 | 193d? |  |  | S1 | 1544h | 1544h | NetSel | 22.811 | Rel-7 | Alain |  | NetSel | O2 | chris.friel@O2.com |  |  |  |
| 7448 | 2353 | Study on Multimedia Priority Service |  | 851d? | 2003-03-28 A | 2006-06-30 A | 100% |  | 2003-03-28 | 2006-06-30 | 851d? |  | finish no earlier than 2005-12-16 | S1 | 6808h | 6808h | PRIOR-MM | 22.953 | Rel-7 | Alain |  | PRIOR-MM | Telcordia | James Garrahan (jgarraha@telcordia.com) |  |  | Public Safety (I-A) |
| 7449 | 2354 | Study on Transferring of emergency Call data |  | 190d? | 2005-07-11 A | 2006-03-31 A | 100% |  | 2005-07-11 | 2006-03-31 | 190d? |  | finish no earlier than 2005-12-08 | S1 | 1520h | 1520h | eCALL | 22.967 | Rel-7 | Alain |  | eCALL | Motorola | jian.j.wu@motorola.com |  |  | Public Safety (I-A) |
| 7450 | 2355 | Study on Enhancement of E2E QoS |  | 281.4d? | 2004-06-28 A | 2005-09-15 A | 100% |  | 2004-06-28 | 2005-09-15 | 281.4d? |  | finish no earlier than 2005-12-01 | S2 | 2251.2h | 2251.2h | QoS7 | 23.802 | Rel-7 | Maurice |  | QoS7 | Huawei | Robert Jaksa |  |  |  |
| 7451 | 2356 | Study on SOAP/HTTP IRP Solution Sets |  | 330d? | 2005-09-02 A | 2006-12-07 A | 100% |  | 2005-09-02 | 2006-12-07 | 330d? |  | finish no earlier than 2006-12-07 | S5 | 2640h | 2640h | OAM7-NIM-XML | 32.809 | Rel-7 | Mirko |  | OAM7-NIM-XML | Nortel | Suzèle Lariven (lariven@nortel.com) |  |  |  |
| 7452 | 2357 | Study on Itf-N Implementation Conformance Statement (ICS) template |  | 400d? | 2005-09-02 A | 2007-03-15 A | 100% |  | 2005-09-02 | 2007-03-15 | 400d? |  | finish no earlier than 2007-03-15 | S5 | 3200h | 3200h | OAM7-NIM-ICS | 32.812 | Rel-7 | Mirko |  | OAM7-NIM-ICS | China Mobile | Li Yewen (liyewen@chinamobile.com) |  |  |  |
| 7453 | 2358 | Study on IRP Information Model |  | 400d? | 2005-09-02 A | 2007-03-15 A | 100% |  | 2005-09-02 | 2007-03-15 | 400d? |  | finish no earlier than 2007-03-15 | S5 | 3200h | 3200h | OAM7-NIM-IM | 32.810 | Rel-7 | Mirko |  | OAM7-NIM-IM | Motorola | trevor.pirt@motorola.com |  |  |  |
| 7454 | 2359 | Study on Bandwidth Saving at Nb Interface with IP transport |  | 261d? | 2006-03-10 A | 2007-03-09 A | 100% |  | 2006-03-10 | 2007-03-09 | 261d? |  | finish no earlier than 2007-03-09 | C3 | 2088h | 2088h | BSNbIP | 29.814 | Rel-7 | Adrian |  | BSNbIP | Siemens | Thomas.Belling@siemens.com |  |  |  |
| 7455 | 2360 | Study on Routeing of MT-SMS via the HPLMN |  | 301d? | 2005-10-07 A | 2006-12-01 A | 100% |  | 2005-10-07 | 2006-12-01 | 301d? |  | finish no earlier than 2006-12-01 | C4 | 2408h | 2408h | SMS7 | 23.840 | Rel-7 | Kimmo |  | SMS7 | Vodafone | Nick.Russell@vodafone.com |  |  |  |
| 7456 | 2361 | Feasibility Study on the TCAPsec Gateway concept |  | 96d? | 2005-10-28 A | 2006-03-10 A | 100% |  | 2005-10-28 | 2006-03-10 | 96d? |  | finish no earlier than 2006-03-10 | C4 | 768h | 768h | FS_SEC7-TCAP | 29.800 | Rel-7 | Kimmo |  | FS_SEC7-TCAP | Siemens | Ulrich.wiehe@gksag.de |  |  |  |
| 7457 | 2362 | Study on using M2PA in 3GPP network |  | 318d? | 2006-03-22 A | 2007-06-08 A | 100% |  | 2006-03-22 | 2007-06-08 | 318d? |  | finish no earlier than 2007-06-08 | C4 | 2544h | 2544h | FS-M2PA | 29.801 | Rel-7 | Kimmo |  | FS-M2PA | China Mobile | zhaoyuyi@chinamobile.com |  |  |  |

Notes:
- 7434: -
- 7435: DAB - Not yet required in SA2 as it exists in previous releases
- 7436: -
- 7437: -
- 7438: Stage 2 description of Interim conclusion
- 7439: Created at TSG#27 by A. Sultan because of the move to Rel-7 of "Common Objects".
- 7440: No progress in CN4#26. This have to be moved to Rel-7. It was deleted from WID
- 7441: -
- 7442: Spin-off Feature UID_7038 (MTSI)
- 7443: -
- 7444: -
- 7445: 07/08 Moved to Rel-7 as Study out of stopped Rel-8 Feature UID_31067 All-IP Network (AIPN)
- 7446: -
- 7447: Spin-off Feature Network selection enhancements (NSP-CR) UID_7041
- 7448: Spin-off Feature PRIOR UID_340044
- 7449: -
- 7450: -
- 7451: SP#34 completed
- 7452: SP#35 completed
- 7453: SP#35 completed
- 7454: Moved to FS at CT32 (in line with slides)
- 7455: Previously known as "Study of a SMS Centre for MT SMS"
- 7456: TR 29.800 content moved to TS 29.204 under implementation WI UID_310005 TCAPsec Gateway
- 7457: -

| ID | WBS | Task | Type | Duration | Start | Finish | Complete | Baseline start | Baseline finish | Baseline duration | Constraint | Resources | Work | Actual work | Acronym | Impacted TSs and TRs | WI rapporteur name | WI rapporteur e-mail | Release | MCC resp | Acronym_3GU_Export | Status Report | TSG stopped | Special Focus Doc |
| --- | --- | --- | --- | --- | --- | --- | --- | --- | --- | --- | --- | --- | --- | --- | --- | --- | --- | --- | --- | --- | --- | --- | --- | --- |
| 7458 | 2363 | **Study on Support of (G)MSC-S - (G)MSC-S Nc Interface based on the SIP-I protocol** |  | 350d? | 2006-05-15 A | 2007-09-14 A | 100% | 2006-05-15 | 2007-09-14 | 350d? |  | C4; C3 | 10600h | 10600h | NcSIP | 29.802 | Vodafone | david.hutton@vodafone.com | Rel-7 | Kimmo | NcSIP |  |  |  |
| 7459 | 2363.1 | CT4 aspects of NcSIP |  | 275d? | 2006-05-15 A | 2007-06-01 A | 100% | 2006-05-15 | 2007-06-01 | 275d? | finish no earlier than 2007-06-01 | C4 | 2200h | 2200h |  | 29.802 | Vodafone | david.hutton@vodafone.com | Rel-7 | Kimmo |  |  |  |  |
| 7460 | 2363.2 | CT3 aspects of NcSIP |  | 350d? | 2006-05-15 A | 2007-09-14 A | 100% | 2006-05-15 | 2007-09-14 | 350d? | finish no earlier than 2007-09-14 | C3 | 2800h | 2800h |  | 29.802 | Ericsson | ragnar.huslende@ericsson.com | Rel-7 | Adrian |  |  |  |  |
| 7461 | 2364 | Study on Evolved UTRA and UTRAN |  | 458d? | 2004-12-15 A | 2006-09-15 A | 100% | 2004-12-15 | 2006-09-15 | 458d? | finish no earlier than 2006-09-15 | RP | 3664h | 3664h | RANFS-Evo | 25.912 | NTT DoCoMo | nakamurata@NTTDOCOMO.CO.JP | Rel-7 | Issam | RANFS-Evo | RP-060472 |  |  |
| 7462 | 2365 | Study on Performance Evaluation of the UE behaviour in high speed trains with speeds up to 350 kmph |  | 328d? | 2005-03-15 A | 2006-06-15 A | 100% | 2005-03-15 | 2006-06-15 | 328d? | finish no earlier than 2006-06-15 | R4 | 2624h | 2624h | RANFS-HSTrains | none | Vodafone | Mike.vogel@vodafone.com,tim.frost@vodafone.com | Rel-7 | Issam | RANFS-HSTrains | RP-060412 |  |  |
| 7463 | 2366 | Study on UTRA Tower Mounted Amplifier (FDD) |  | 195d? | 2005-06-15 A | 2006-03-14 A | 100% | 2005-06-15 | 2006-03-14 | 195d? | finish no earlier than 2006-03-15 | R4 | 1560h | 1560h | RANFS-TMA | 25.818 | Ericsson | Klas.Sjerling@ericsson.com | Rel-7 | Issam | RANFS-TMA | RP-060035 |  |  |
| 7464 | 2367 | Study on Continuous connectivity for packet data users |  | 132d? | 2005-03-15 A | 2005-09-14 A | 100% | 2005-03-15 | 2005-09-14 | 132d? | finish no earlier than 2005-09-15 | R1 | 1056h | 1056h | RANFS-cont-packet | none | Siemens | joerg.gustrau@siemens.com | Rel-7 | Patrick | RANFS-cont-packet | RP-050427 |  |  |
| 7465 | 2368 | Study on Improvement of the Multimedia Broadcast Multicast Service (MBMS) in UTRAN |  | 262d? | 2005-12-15 A | 2006-12-15 A | 100% | 2005-12-15 | 2006-12-15 | 262d? | finish no earlier than 2006-12-15 | R2 | 2096h | 2096h | RANFS-MBMSImp | 25.905 | LG Electronics | leego@lge.com | Rel-7 | Yong-Jun | RANFS-MBMSImp | RP-060692 |  |  |
| 7466 | 2369 | Deleted - Study on Performance Improvements in Small Cells using HSDPA/EDCH |  | 131d? | 2005-12-15 A | 2006-06-15 A | 100% | 2005-12-15 | 2006-06-15 | 131d? | finish no earlier than 2006-06-15 | R1; R4 | 2096h | 2096h | SMALLCELLS | none | Cingular | Marc Grant | Rel-7 | Issam | SMALLCELLS | RP-060263 | SP-69 | Small cell |
| 7467 | 2370 | Study on Further Improved Performance Requirements for UMTS/HSDPA UE (FDD) |  | 383d? | 2005-12-15 A | 2007-06-04 A | 100% | 2005-12-15 | 2007-06-04 | 383d? | finish no earlier than 2007-06-04 | R4 | 3064h | 3064h | RANFS-IC | 25.963 | Cingular | Marc Grant | Rel-7 | Issam | RANFS-IC | RP-070499 |  |  |
| 7468 | 2371 | Study on Scope of future FDD HSPA Evolution |  | 394d? | 2006-03-15 A | 2007-09-17 A | 100% | 2006-03-15 | 2007-09-17 | 394d? | finish no earlier than 2007-09-17 | RP | 3152h | 3152h | RANFS-HSPAEvo | 25.999 | Cingular | Don Zelmer (dz1069@att.com) | Rel-7 | Issam | RANFS-HSPAEvo | RP-070533 |  |  |
| 7469 | 2372 | Study on Dynamically reconfiguring a FDD UE receiver to reduce power consumption when desired Quality of Service is met | milestone | 0d? | 2007-06-22 A | 2007-06-22 A | 100% | 2007-06-22 | 2007-06-22 | 0d? |  | R4 |  |  | FSUEPow | 25.906 | Nokia | Chris.callender@nokia.com, tiina.s.koskinen@nokia.com | Rel-7 | Issam | FSUEPow | RP-070534 |  |  |
| 7470 | 2373 | Study on Future GERAN Evolution |  | 486d? | 2005-04-08 A | 2007-02-16 A | 100% | 2005-04-08 | 2007-02-16 | 486d? | finish no earlier than 2007-02-16 | GP | 3888h | 3888h | FGE | 45.912 | Nokia | eddie.riddington@nokia.com | Rel-7 | Paolo | FGE |  |  |  |
| 7471 | 2374 | Study on GAN Enhancements | milestone | 0d? | 2007-08-31 A | 2007-08-31 A | 100% | 2007-08-31 | 2007-08-31 | 0d? | start no earlier than 2007-08-31 | GP |  |  | EGAN | 43.902 | T-Mobile | janne.linkola@t-mobile.com | Rel-7 | Paolo | EGAN |  |  |  |
| 7472 | 2375 | Deleted - Study on IMS with real time services deployment |  | 316d? | 2004-06-28 A | 2005-09-12 A | 100% | 2004-06-28 | 2005-09-12 | 316d? |  | S1 | 2528h | 2528h | IRTSD |  |  |  | Rel-7 | Alain | IRTSD |  | SP-30 |  |
| 7473 | 2376 | Deleted - Covered by SI - Personal Network (PN) and Personal Area Network (PAN) | milestone | 0d? | 2005-12-08 A | 2005-12-08 A | 100% | 2005-12-08 | 2005-12-20 | 0d? | start no earlier than 2005-12-08 | S1 |  |  | PNPAN |  | Vodafone | armin.toepfer@vodafone.com | Rel-7 | Alain | PNPAN |  | SP-30 |  |
| 7474 | 2377 | Deleted - Study on Customised Alerting Tone (CAT) Requirements (was duplicated) | milestone | 0d? | 2006-06-30 A | 2006-06-30 A | 100% | 2006-06-30 | 2006-06-30 | 0d? | start no earlier than 2006-06-30 | S1 |  |  |  |  |  |  | Rel-7 | Alain |  |  | SP-31 |  |
| 7475 | 2378 | Deleted - IMS security extensions (covered by UID33027) | milestone | 0d? | 2005-12-08 A | 2005-12-08 A | 100% | 2005-12-08 | 2005-12-08 | 0d? | start no earlier than 2005-12-08 | S3 |  |  | IMS-SE |  | Ericsson | Bengt.Sahlin@ericsson.com | Rel-7 | Mirko | IMS-SE |  | SP-30 |  |
| 7476 | 2379 | **Deleted - Study on applicability of GALILEO for LCS** |  | 0d? | 2005-06-30 A | 2005-06-30 A | 100% | 2005-06-30 | 2005-06-30 | 0d? |  | S2 |  |  | Galileo |  |  |  | Rel-7 | Maurice | Galileo |  | SP-25 |  |
| 7477 | 2379.1 | Deleted - TR on Stage 2 | milestone | 0d? | 2005-06-30 A | 2005-06-30 A | 100% | 2005-06-30 | 2005-06-30 | 0d? | finish no earlier than 2005-06-30 | S2 |  |  |  |  |  |  | Rel-7 | Maurice |  |  | SP-25 |  |
| 7478 | 2379.2 | Deleted - GERAN review of the TR | milestone | 0d? | 2005-06-30 A | 2005-06-30 A | 100% | 2005-06-30 | 2005-06-30 | 0d? | start no earlier than 2005-06-30 | GP |  |  |  |  |  |  | Rel-7 | Paolo |  |  | SP-26 |  |
| 7479 | 2380 | Deleted - Study on Stage 2 (IMS services using CS bearers) |  | 316d? | 2004-06-28 A | 2005-09-12 A | 100% | 2004-06-28 | 2005-09-12 | 316d? | finish no earlier than 2005-09-12 | S2 | 2528h | 2528h | IRTSD-IMSCS | 23.899 | Nortel | Mark Watson | Rel-7 | Maurice | IRTSD-IMSCS |  | SP-30 |  |
| 7480 | 2381 | **Deleted - VoIMS bearer related enhancements** |  | 0d? | 2006-07-21 A | 2006-07-21 A | 100% | 2006-07-21 | 2006-07-21 | 0d? |  | S2 |  |  | VoIMS |  |  |  | Rel-7 | Maurice | VoIMS |  | SP-32 |  |
| 7481 | 2381.1 | Deleted - Study on enhancement of radio performance for VoIMS | milestone | 0d? | 2006-07-21 A | 2006-07-21 A | 100% | 2006-07-21 | 2006-07-21 | 0d? | start no earlier than 2006-07-21 | S2 |  |  |  | 23.807 | Nortel | Laurence Lautier (lautierl@nortel.com) | Rel-7 | Maurice |  |  | SP-32 |  |
| 7482 | 2382 | Deleted - Study on IMS enhancements and optimizations for real time communication. |  | 430d? | 2005-10-10 A | 2007-06-01 A | 100% | 2005-10-10 | 2007-06-01 | 430d? | finish no earlier than 2007-06-01 | S2 | 3440h | 3440h | IMS-RT | 23.818 | Ericsson | stephen.terrill@ericsson.com | Rel-7 | Maurice | IMS-RT |  | SP-35 |  |
| 7483 | 2383 | Deleted - Study on Terminating Session handling |  | 255d? | 2006-01-09 A | 2006-12-29 A | 100% | 2006-01-09 | 2006-12-29 | 255d? | finish no earlier than 2006-12-29 | S2 | 2040h | 2040h | CSIterm | 23.819 | Samsung |  | Rel-7 | Maurice | CSIterm |  | SP-32 |  |
| 7484 | 2384 | Deleted eCALLIBMS - Study on Transferring of emergency call data – in-band modem solution (moved to Rel-8) | milestone | 0d? | 2007-06-22 A | 2007-06-22 A | 100% | 2007-06-22 | 2007-06-22 | 0d? | start no earlier than 2007-06-22 | S4 |  |  |  | 26.967 | Airbiquity | lhong@airbiquity.com | Rel-7 | Paolo |  |  | SP-38 | Public Safety (I-A) |
| 7485 | 2385 | Deleted - Study on IRP usage scenarios |  | 330d? | 2005-09-02 A | 2006-12-07 A | 100% | 2005-09-02 | 2006-12-07 | 330d? | finish no earlier than 2006-12-07 | S5 | 2640h | 2640h | OAM-Study | 32.8xy | Lucent |  | Rel-7 | Mirko | OAM-Study |  | SP-32 |  |
| 7486 | 2386 | Deleted - Study on Interference Cancellation for UTRA FDD UE (covered by UID 20053) |  | 1d? | 2007-03-28 A | 2007-03-28 A | 100% | 2007-03-28 | 2007-03-28 | 1d? | start no earlier than 2007-03-28 | R4 | 8h | 8h | RANFS-InterfCanc |  |  |  | Rel-7 | Issam | RANFS-InterfCanc |  | SP-38 |  |
| 7487 | 2387 | Deleted - Study on enhanced support of Video Telephony | milestone | 0d? | 2006-06-30 A | 2006-06-30 A | 100% | 2006-06-30 | 2006-06-30 | 0d? | start no earlier than 2006-06-30 | GP |  |  | VIDGER |  | Ericsson | stefan.g.eriksson@ericsson.com | Rel-7 | Paolo | VIDGER |  | SP-32 |  |
| 7488 | 2388 | --- RELEASE 6 --- |  | 915d? | 2002-06-28 A | 2005-12-30 A | 100% | 2002-06-28 | 2005-12-30 | 915d? |  | NP; GP; RP; SP; TP | 36600h | 36600h |  |  |  |  | Rel-6 | All |  |  |  |  |

Notes:
- 7458: -
- 7459: -
- 7460: -
- 7461: RP#33 (Sep 2006) completed. SR in RP-060472
- 7462: RP#32 (Jun 2006) completed. SR in RP-060412
- 7463: RP#31 (Mar 2006) completed. SR in RP-060035
- 7464: RP#29 (Sep 2006) completed. SR in RP-050427
- 7465: RP#34 completed
- 7466: RP#32 (Jun 2006) stopped at 0% completion
- 7467: RP#36 (May 2007) completed. SR in RP-070499
- 7468: RP#37 (Sep 2007) completed. SR in RP-070533
- 7469: RP#37 (Sep 2007) completed. SR in RP-070534
- 7470: GP#33 completed
- 7471: GP#35 completed
- 7472: -
- 7473: -
- 7474: Awaiting MCC SA3 input
- 7475: -
- 7476: -
- 7477: -
- 7478: -
- 7479: SP-30: S2 has no intention for TR completion
- 7480: Created by MCC to group all VoIMS related items, after consultation of chairs
- 7481: WID approved SP#28. SA2#52 stopped
- 7482: abandoned at 65%
- 7483: SP#32 Jun 2006 Study abandoned => spin-off Implementation work UID_320029
- 7484: SP-38 stopped
- 7485: -
- 7486: Deleted. Same as FS on Further Improved Performance Requirements for UMTS/HSDPA UE (FDD)
- 7487: FS CLOSED at G#28 (no input)
- 7488: -

| ID | WBS | Task | Type | Duration | Start | Finish | Complete | Baseline start | Baseline finish | Baseline duration | Constraint | Resources | Work | Actual work | Release | Acronym | WI rapporteur name | WI rapporteur e-mail | MCC resp | Acronym_3GU_Export | Impacted TSs and TRs | Created at | TSG stopped |
| --- | --- | --- | --- | --- | --- | --- | --- | --- | --- | --- | --- | --- | --- | --- | --- | --- | --- | --- | --- | --- | --- | --- | --- |
| 7489 | 8 | **Rel-6 Improvements of Radio Interface** |  | 1645d? | 2000-08-14 A | 2006-12-01 A | 100% | 2000-08-14 | 2006-12-01 | 1645d? |  | R2; R4; R5 | 87632h | 87632h | Rel-6 |  |  |  |  |  |  |  |  |
| 7490 | 2389.1 | Improved support of IMS Realtime Services using HSDPA/EDCH |  | 197d? | 2005-03-15 A | 2005-12-14 A | 100% | 2005-03-15 | 2005-12-14 | 197d? | finish no earlier than 2005-12-14 | R2 | 1576h | 1576h | Rel-6 | RInImp-IMSRealTime | Cingular | Don Zelmer (dz1069@att.com) | Yong-Jun | RInImp-IMSRealTime |  |  |  |
| 7491 | 2389.2 | Improving Receiver Performance Requirements for the FDD UE |  | 401d | 2002-03-08 A | 2003-09-19 A | 100% | 2002-03-08 | 2003-09-19 | 401d | start no earlier than 2002-03-08 | R4 | 3208h | 3208h | Rel-6 | RInImp-UERecPerf | Intel | shimon.moshavi@INTEL.COM | Issam | RInImp-UERecPerf | 25.101 |  |  |
| 7492 | 8.2 | **Base station classification for FDD** |  | 603d | 2000-08-14 A | 2002-12-04 A | 100% | 2000-08-14 | 2002-12-04 | 603d |  | R4 | 9648h | 9648h | Rel-6 | RInImp-BSClass-FDD |  |  | Issam | RInImp-BSClass-FDD |  |  |  |
| 7493 | 8.2.1 | FDD Base station classification |  | 603d | 2000-08-14 A | 2002-12-04 A | 100% | 2000-08-14 | 2002-12-04 | 603d | finish no earlier than 2002-12-04 | R4 | 4824h | 4824h | Rel-6 |  | Nokia | antti.toskala@nokia.com | Issam |  | 25.104; 25.141 |  |  |
| 7494 | 2389.4 | UMTS-850 |  | 266d | 2002-12-06 A | 2003-12-12 A | 100% | 2002-12-06 | 2003-12-12 | 266d | finish no earlier than 2003-12-15 | R4 | 2128h | 2128h | Rel-6 | RInImp-UMTS850 | Cingular | Don Zelmer (dz1069@att.com) | Issam | RInImp-UMTS850 | 25.101; 25.104; 25.133; 25.141; 25.307; 25.331; 25.942 |  |  |
| 7495 | 2389.5 | DS-CDMA introduction in the 800 MHz band |  | 196d | 2003-03-14 A | 2003-12-12 A | 100% | 2003-03-14 | 2003-12-12 | 196d | finish no earlier than 2003-12-15 | R4 | 1568h | 1568h | Rel-6 | RInImp-UMTS800 | NTT DoCoMo | Takehiro Nakamura (nakamurata@nttdocomo.co.jp) | Issam | RInImp-UMTS800 | 25.101; 25.104; 25.133; 25.141; 25.307; 25.331 |  |  |
| 7496 | 2389.6 | UMTS 1.7/2.1 GHz | milestone | 0d? | 2003-03-14 A | 2003-03-14 A | 100% | 2003-03-14 | 2003-03-14 | 0d? |  | R4 |  |  | Rel-6 | RInImp-UMTS1721 | Nokia | jussi.numminen@NOKIA.COM | Issam | RInImp-UMTS1721 | 25.101; 25.104; 25.133; 25.141; 25.307; 25.331 |  |  |
| 7497 | 2389.7 | Conformance Test Aspects – UMTS 1.7/2.1 GHz Band |  | 191d? | 2006-03-10 A | 2006-12-01 A | 100% | 2006-03-10 | 2006-12-01 | 191d? | finish no earlier than 2006-12-01 | R5 | 1528h | 1528h | Rel-6 | RInImp-UMTS1721_Test | Motorola | carolyn.taylor@motorola.com | Ingbert | RInImp-UMTS1721_Test | TS34.121; TS34.108 |  |  |
| 7498 | 2389.8 | **Improved Receiver Performance Requirements for HSDPA** |  | 711d | 2003-09-19 A | 2006-06-09 A | 100% | 2003-09-19 | 2006-06-09 | 711d |  | R4; R5 | 28496h | 28496h | Rel-6 | RInImp-HSPerf | Nokia | jussi.numminen@NOKIA.COM | Issam | RInImp-HSPerf |  |  |  |
| 7499 | 2389.8.1 | Improved Minimum Performance Requirements for HSDPA UE categories 7 and 8 |  | 453d | 2004-09-15 A | 2006-06-09 A | 100% | 2004-09-15 | 2006-06-09 | 453d |  | R4 | 3624h | 3624h | Rel-6 | RInImp-HSPerf-10code | Nokia | jussi.numminen@nokia.com | Issam | RInImp-HSPerf-10code | 25.101 |  |  |
| 7500 | 2389.8.2 | Testing of Improved Minimum Performance for HSDPA |  | 650d | 2003-09-19 A | 2006-03-16 A | 100% | 2003-09-19 | 2006-03-16 | 650d | finish no earlier than 2006-03-16 | R5 | 5200h | 5200h | Rel-6 | RInImp-HSPerf-10Code_Test | Motorola | carolyn.taylor@motorola.com | Ingbert | RInImp-HSPerf-10Code_Test | 34.108; 34.121; 34.122; 34.123-1; 34.123-2; 34.123-3 | 19/9/2003 |  |
| 7501 | 2389.8.3 | Performance Requirements of Receive Diversity for HSDPA |  | 387d | 2003-12-15 A | 2005-06-07 A | 100% | 2003-12-15 | 2005-06-07 | 387d |  | R4 | 3096h | 3096h | Rel-6 | RInImp-HSPerf-RxDiv | NTT DoCoMo | Takehiro Nakamura (nakamurata@nttdocomo.co.jp) | Issam | RInImp-HSPerf-RxDiv | 25.101 |  |  |
| 7502 | 2389.8.4 | Testing of Performance of Receiver diversity for HSDPA |  | 650d | 2003-09-19 A | 2006-03-16 A | 100% | 2003-09-19 | 2006-03-16 | 650d | finish no earlier than 2006-03-16 | R5 | 5200h | 5200h | Rel-6 | RInImp-HSPerf-RxDiv_Test | Motorola | carolyn.taylor@motorola.com | Ingbert | RInImp-HSPerf-RxDiv_Test | 34.108; 34.121; 34.122; 34.123-1; 34.123-2; 34.123-3 | 19/9/2003 |  |
| 7503 | 2390 | **Rel-6 RAN Feasibility Studies** |  | 1196d? | 2000-08-14 A | 2005-03-14 A | 100% | 2000-08-14 | 2005-03-14 | 1196d? |  | RP | 43048h | 43048h | Rel-6 |  |  |  |  |  |  |  |  |
| 7504 | 2390.1 | FS of the improved access to UE measurement data for CRNC to support TDD RRM |  | 270d? | 2002-12-06 A | 2003-12-18 A | 100% | 2002-12-06 | 2003-12-18 | 270d? | finish no earlier than 2003-09-19 | R3 | 2160h | 2160h | Rel-6 | RANimp-RRMopt-FSUEMsD | Interdigital | jim.miller@interdigital.com | Juha | RANimp-RRMopt-FSUEMsD | 25.801; 25.423 | SP-24 |  |
| 7505 | 2390.2 | FS on Radio link performance enhancements |  | 1067d | 2000-08-14 A | 2004-09-14 A | 100% | 2000-08-14 | 2004-09-14 | 1067d | finish no earlier than 2004-09-14 | R1 | 8536h | 8536h | Rel-6 | RInImp-Rlperf | Nokia | antti.toskala@nokia.com | Patrick | RInImp-Rlperf | 25.899 |  |  |
| 7506 | 2390.3 | FS on Improvement of inter-frequency and inter-system measurements for 1.28 Mcps TDD |  | 461d | 2001-12-14 A | 2003-09-19 A | 100% | 2001-12-14 | 2003-09-19 | 461d | start no earlier than 2001-12-14 | R1 | 3688h | 3688h | Rel-6 | RInImp-IfIsMLCR | Samsung | Li Xiao Qiang (xqli@samsung.co.kr) | Patrick | RInImp-IfIsMLCR | 25.888 |  |  |
| 7507 | 2390.4 | FS for the analysis of OFDM for UTRAN enhancement |  | 526d | 2002-06-10 A | 2004-06-14 A | 100% | 2002-06-10 | 2004-06-14 | 526d | start no earlier than 2002-06-10 | R1 | 4208h | 4208h | Rel-6 | RInImp-FSOFDM | Nortel | Sarah Boumendil | Patrick | RInImp-FSOFDM | 25.892 |  |  |
| 7508 | 2390.5 | FS on Uplink Enhancements for Dedicated Transport Channels |  | 396d | 2002-09-06 A | 2004-03-12 A | 100% | 2002-09-06 | 2004-03-12 | 396d | finish no earlier than 2004-03-12 | R1 | 3168h | 3168h | Rel-6 | RInImp-FSUpDTrCh | Nokia | Karri.Ranta-aho@nsn.com | Patrick | RInImp-FSUpDTrCh | 25.896 |  |  |
| 7509 | 2390.6 | FS on Analysis on Higher Chip Rates for UTRA TDD evolutions |  | 528d | 2002-09-06 A | 2004-09-14 A | 100% | 2002-09-06 | 2004-09-14 | 528d | finish no earlier than 2004-09-14 | R1 | 4224h | 4224h | Rel-6 | RInImp-FSVHCRTDD | IPWireless | mbeale@ipwireless.com | Patrick | RInImp-FSVHCRTDD | 25.895 |  |  |
| 7510 | 2390.7 | FS on Low Output Powers for general purpose FDD BSs |  | 128d | 2003-06-13 A | 2004-03-12 A | 100% | 2003-06-13 | 2004-03-12 | 128d | finish no earlier than 2004-03-12 | R3 | 1024h | 1024h | Rel-6 | RInImp-FSLoPw | Telefónica | Ana Burgos (burgos_a@tsm.es) | Juha | RInImp-FSLoPw | 25.807 |  |  |
| 7511 | 2390.8 | FS on Uplink enhancements for UTRA TDD |  | 462d | 2003-06-06 A | 2005-03-14 A | 100% | 2003-06-06 | 2005-03-14 | 462d | finish no earlier than 2005-03-14 | R1 | 3696h | 3696h | Rel-6 | RInImp-FSUpEnhTDD | Interdigital | Marian.Rudolf@InterDigital.com | Patrick | RInImp-FSUpEnhTDD | 25.804 |  |  |
| 7512 | 8.8 | FS on UE antenna efficiency test methods performance requirements (2) |  | 131d | 2002-03-08 A | 2002-09-06 A | 100% | 2002-03-08 | 2002-09-06 | 131d | finish no earlier than 2002-09-06 | R4 | 1048h | 1048h | Rel-6 | RInImp-UEAnTM2 | Allgon | Alf Ahlström (alf.ahlstrom@pwav.com) | Issam | RInImp-UEAnTM2 |  |  |  |
| 7513 | 9.4 | Deleted - FS on the evolution of the UTRAN architecture |  | 592d | 2002-09-09 A | 2004-12-14 A | 100% | 2002-09-09 | 2004-12-14 | 592d | finish no earlier than 2004-12-15 | R3 | 4736h | 4736h | Rel-6 | RANimp-FSEvo | Nokia | woonhee.hwang@nsn.com, Antti.Toskala@nokia.com | Juha | RANimp-FSEvo |  |  | RP-26 |

Notes:
- 7489: -
- 7490: -
- 7491: -
- 7492: -
- 7493: -
- 7494: Introduction of UMTS850 (Band V) in 25.307
- 7495: Introduction of UMTS800 in 25.307
- 7496: Introduction of UMTS1700/2100 (Band IV)
- 7497: -
- 7498: -
- 7499: Approved at RP#25 as RP-040375
- 7500: -
- 7501: -
- 7502: -
- 7503: -
- 7504: -
- 7505: Study finished at RP#25
- 7506: -
- 7507: -
- 7508: -
- 7509: Study finished at RP#25
- 7510: -
- 7511: -
- 7512: The RInImp-UEAnTM FS was re-opened at TSG RP#15 upon request from WG4
- 7513: Study Closed, work will continue within the FS on evolved UTRA and UTRAN

| ID | WBS | Task | Type | Duration | Start | Finish | Complete | Baseline start | Baseline finish | Baseline duration | Constraint | Deadline | Resources | Work | Actual work | Acronym | WI rapporteur name | WI rapporteur e-mail | Release | MCC resp | Acronym_3GU_Export | Impacted TSs and TRs | Created at | TSG stopped |
| --- | --- | --- | --- | --- | --- | --- | --- | --- | --- | --- | --- | --- | --- | --- | --- | --- | --- | --- | --- | --- | --- | --- | --- | --- |
| 7514 | 2391 | **FDD Enhanced Uplink** |  | 915d | 2004-03-15 A | 2007-09-14 A | 100% | 2004-03-15 | 2007-09-14 | 915d |  |  | R2; R1; R3; R4; R5 | 49800h | 49800h | EDCH | Ericsson | Joakim Bergström | Rel-6 | Yong-Jun | EDCH |  |  |  |
| 7515 | 2391.1 | FDD Enhanced Uplink - Stage 2 |  | 197d | 2004-03-15 A | 2004-12-14 A | 100% | 2004-03-15 | 2004-12-14 | 197d | finish no earlier than 2004-12-14 |  | R2 | 1576h | 1576h | EDCH-Stage2 |  |  | Rel-6 | Yong-Jun | EDCH-Stage2 | 25.309 |  |  |
| 7516 | 2391.2 | FDD Enhanced Uplink - Physical Layer |  | 261d | 2004-03-15 A | 2005-03-14 A | 100% | 2004-03-15 | 2005-03-14 | 261d | finish no earlier than 2005-03-14 |  | R1 | 2088h | 2088h | EDCH-Phys | Nokia | Karri.Ranta-aho@nsn.com | Rel-6 | Patrick | EDCH-Phys | 25.211; 25.212; 25.213; 25.214; 25.215 |  |  |
| 7517 | 2391.3 | FDD Enhanced Uplink - Layer 2 and 3 Protocol Aspects |  | 261d | 2004-03-15 A | 2005-03-14 A | 100% | 2004-03-15 | 2005-03-14 | 261d | finish no earlier than 2005-03-14 |  | R2 | 2088h | 2088h | EDCH-L23 | Ericsson | Joakim Bergström | Rel-6 | Yong-Jun | EDCH-L23 | 25.301; 25.302; 25.306; 25.321; 25.331 |  |  |
| 7518 | 2391.4 | FDD Enhanced Uplink - UTRAN Iub/Iur Protocol Aspects |  | 261d | 2004-03-15 A | 2005-03-14 A | 100% | 2004-03-15 | 2005-03-14 | 261d | finish no earlier than 2005-03-14 |  | R3 | 2088h | 2088h | EDCH-IurIub | Nortel | Saso Stojanovski | Rel-6 | Juha | EDCH-IurIub | 25.401; 25.420; 25.423; 25.430; 25.433 |  |  |
| 7519 | 2391.5 | FDD Enhanced Uplink - RF Radio Transmission/ Reception, System Performance Requirements and Conformance Testing |  | 74d | 2004-03-15 A | 2004-06-24 A | 100% | 2004-03-15 | 2004-06-24 | 74d |  |  | R4 | 592h | 592h | EDCH-RF | Ericsson | thomas.unshelm@ericsson.com | Rel-6 | Issam | EDCH-RF | 25.101; 25.104; 25.133; 25.141 |  |  |
| 7520 | 2391.6 | Conformance Test Aspects – FDD Enhanced Uplink |  | 596d | 2005-06-03 A | 2007-09-14 A | 100% | 2005-06-03 | 2007-09-14 | 596d | finish no earlier than 2007-09-14 | 2006-06-02 | R5 | 4768h | 4768h | EDCH_Test | Ericsson | Leif.Mattisson@ericsson.com | Rel-6 | Ingbert | EDCH_Test | 34.108; 34.109; 34.121; 34.123-1; 34.123-2; 34.123-3 | Fri 03/06/05 |  |
| 7521 | 2392 | **Rel-6 RAN improvements** |  | 656d? | 2002-09-09 A | 2005-03-14 A | 100% | 2002-09-09 | 2005-03-14 | 656d? |  |  | RP; S5 | 36720h | 36720h |  |  |  | Rel-6 |  |  |  |  |  |
| 7522 | 9.2 | **RAB support enhancement** |  | 522d? | 2003-03-14 A | 2005-03-14 A | 100% | 2003-03-14 | 2005-03-14 | 522d? |  |  | R2 | 9360h | 9360h |  | Nokia | Jussi Kähtävä (juha.mikola@nokia.com) | Rel-6 | Yong-Jun |  | 25.862 |  |  |
| 7523 | 2392.1.1 | Optimization of downlink channelisation code utilisation |  | 262d | 2004-03-12 A | 2005-03-14 A | 100% | 2004-03-12 | 2005-03-14 | 262d | finish no earlier than 2005-03-14 |  | R1 | 2096h | 2096h | RANimp-RABSE-CodeOptFDD | Nortel | Sarah Boumendil | Rel-6 | Patrick | RANimp-RABSE-CodeOptFDD |  |  |  |
| 7524 | 2392.1.2 | optimization of channelisation code utilisation for 3.84 Mcps TDD |  | 261d | 2004-03-15 A | 2005-03-14 A | 100% | 2004-03-15 | 2005-03-14 | 261d | finish no earlier than 2005-03-15 |  | R1 | 2088h | 2088h | RANimp-RABSE-CodOptTDD | IPWireless | Nicholas Anderson | Rel-6 | Patrick | RANimp-RABSE-CodOptTDD |  |  |  |
| 7525 | 2392.1.3 | HS-DPCCH ACK/NACK Enhancement |  | 65d? | 2004-09-15 A | 2004-12-14 A | 100% | 2004-09-15 | 2004-12-14 | 65d? | finish no earlier than 2004-12-15 |  | R1 | 520h | 520h | RANimp-RABSE-ACKNACK | Nokia | Jussi Kähtävä (juha.mikola@nokia.com) | Rel-6 | Patrick | RANimp-RABSE-ACKNACK | 25.212; 25.214; 24.331; 25.433 |  |  |
| 7526 | 2392.1.4 | Deleted - Iu enhancements for IMS support in RAN |  | 320d? | 2003-03-14 A | 2004-06-03 A | 100% | 2003-03-14 | 2004-06-03 | 320d? | start no earlier than 2003-03-14 |  | R3 | 2560h | 2560h | RANimp-RABSE-IuEnhIMS | Nortel | Philippe.Godin@nortelnetworks.com | Rel-6 | Juha | RANimp-RABSE-IuEnhIMS |  |  | RP-24 |
| 7527 | 2392.1.5 | Deleted - Improvement of RRM across RNS and RNS/BSS | milestone | 0d? | 2003-12-05 A | 2003-12-05 A | 100% | 2003-12-05 | 2003-12-05 | 0d? | finish no earlier than 2003-12-05 |  | R3 |  |  | RANimp-RRM1 | Nokia | antti.toskala@nokia.com | Rel-6 | Juha | RANimp-RRM1 |  |  | RP-23 |
| 7528 | 9.1 | Beamforming Enhancements |  | 66d | 2003-09-19 A | 2003-12-19 A | 100% | 2003-09-19 | 2003-12-19 | 66d | finish no earlier than 2004-03-12 |  | R1 | 528h | 528h | RANimp-BFE | Nokia | Jussi Kähtävä (juha.mikola@nokia.com) | Rel-6 | Patrick | RANimp-BFE | 24.215; 25.423; 25.425; 25.433; 25.435 |  |  |
| 7529 | 2392.3 | **Rel-6 RRM optimization for Iur and Iub** |  | 126d | 2003-09-19 A | 2004-03-12 A | 100% | 2003-09-19 | 2004-03-12 | 126d |  |  | R3 | 2016h | 2016h | RANimp-RRMopt-UEMsD | Ericsson | Gert-Jan.van.Lieshout@eln.ericsson.se | Rel-6 | Juha | RANimp-RRMopt-UEMsD |  |  |  |
| 7530 | 2392.3.1 | Improved access to UE measurement data for CRNC to support TDD RRM |  | 126d | 2003-09-19 A | 2004-03-12 A | 100% | 2003-09-19 | 2004-03-12 | 126d | finish no earlier than 2004-03-15 |  | R3 | 1008h | 1008h |  | Interdigital | jim.miller@interdigital.com | Rel-6 | Juha |  | 25.423 |  | RP-22 |
| 7531 | 2392.4 | **Remote Control of Electrical Tilting Antennas** |  | 395d? | 2003-03-14 A | 2004-09-16 A | 100% | 2003-03-14 | 2004-09-16 | 395d? |  |  | R3; S5 | 10624h | 10624h | RANimp-TiltAnt | Vodafone | Andreas.Hauser@vodafone.com | Rel-6 | Juha | RANimp-TiltAnt |  |  |  |
| 7532 | 2392.4.1 | Tilting Antenna - RAN aspects |  | 393d? | 2003-03-14 A | 2004-09-14 A | 100% | 2003-03-14 | 2004-09-14 | 393d? | finish no earlier than 2004-09-14 |  | R3 | 3144h | 3144h |  | Vodafone | Andreas.Hauser@vodafone.com | Rel-6 | Juha |  | 25.460; 25.461; 25.462; 25.463 |  |  |
| 7533 | 2392.4.2 | OAM&P impacts |  | 145d | 2004-02-27 A | 2004-09-16 A | 100% | 2004-02-27 | 2004-09-16 | 145d | finish no earlier than 2004-09-16 |  | S5 | 1160h | 1160h | RANimp-TiltAnt-OAM | Vodafone | Adrian.Neal@vodafone.com | Rel-6 | Mirko | RANimp-TiltAnt-OAM | 32.804; 32.64x | SP-24 |  |
| 7534 | 2392.5 | Network Assisted Cell Change (NACC) from UTRAN to GERAN - network-side aspects |  | 462d? | 2002-09-09 A | 2004-06-15 A | 100% | 2002-09-09 | 2004-06-15 | 462d? | finish no earlier than 2004-06-15 |  | R3 | 3696h | 3696h | RANimp-NACC | Vodafone | Brendan.McWilliams@gb.vodafone.co.uk | Rel-6 | Juha | RANimp-NACC |  |  |  |
| 7535 | 12 | **Location Services enhancements 2** |  | 1024d? | 2001-01-15 A | 2004-12-16 A | 100% | 2001-01-15 | 2004-12-16 | 1024d? |  |  | S2; S5; N4; R2; R4; R5; OMA | 175184h | 175184h | LCS2 | Nokia | Jan Kåll | Rel-6 | Maurice | LCS2 |  |  |  |
| 7536 | 12.1 | **Improvement on Le interface** |  | 653d? | 2002-06-17 A | 2004-12-15 A | 100% | 2002-06-17 | 2004-12-15 | 653d? |  |  | S2; OMA | 15096h | 15096h |  | Nokia | Jan Kåll | Rel-6 | Maurice |  |  |  |  |
| 7537 | 2393.1.1 | Stage 2 for Improvement on Le interface |  | 331d? | 2002-06-17 A | 2003-09-22 A | 100% | 2002-06-17 | 2003-09-22 | 331d? | start no earlier than 2002-06-17 |  | S2 | 2648h | 2648h |  | Nokia | Jan Kåll | Rel-6 | Maurice |  | 23.002.23.271 |  |  |
| 7538 | 2393.1.2 | Stage 3 - impacts MLP (Mobile Location Protocol) |  | 250d? | 2004-01-01 A | 2004-12-15 A | 100% | 2004-01-01 | 2004-12-15 | 250d? | finish no earlier than 2004-12-15 |  | OMA | 2000h | 2000h |  | OMA | OMA-LIAISON@mail.openmobilealliance.org | Rel-6 |  |  |  |  |  |

Notes:
- 7514: -
- 7515: -
- 7516: -
- 7517: -
- 7518: -
- 7519: -
- 7520: -
- 7521: Generic feature
- 7522: building block without particular end date
- 7523: -
- 7524: WIDS modified in RP#26, RP-040551
- 7525: Approved at RP#25 as RP-040390
- 7526: Closed RP#24 due to the lack of progress
- 7527: abandoned RP-23
- 7528: -
- 7529: -
- 7530: -
- 7531: -
- 7532: Finished at RP#25
- 7533: SP#25 09/2004 completed
- 7534: -
- 7535: -
- 7536: -
- 7537: -
- 7538: -

| ID | WBS | Task | Type | Duration | Start | Finish | Complete | Baseline start | Baseline finish | Baseline duration | Constraint | Resources | Work | Actual work | WI rapporteur name | WI rapporteur e-mail | Release | MCC resp | Acronym | Acronym_3GU_Export | TSG stopped |
| --- | --- | --- | --- | --- | --- | --- | --- | --- | --- | --- | --- | --- | --- | --- | --- | --- | --- | --- | --- | --- | --- |
| 7539 | 12.2 | **Enhanced support for anonymity and user privacy** |  | 638d? | 2002-07-08 A | 2004-12-15 A | 100% | 2002-07-08 | 2004-12-15 | 638d? |  | S2; OMA | 14248h | 14248h | Nokia | Jan Kåll | Rel-6 | Maurice |  |  |  |
| 7540 | 2393.2.1 | Stage 2 for Enhanced support for anonymity and user privacy |  | 255d? | 2002-07-08 A | 2003-06-27 A | 100% | 2002-07-08 | 2003-06-27 | 255d? | finish no earlier than 2003-06-27 | S2 | 2040h | 2040h | Nokia | Jan Kåll | Rel-6 | Maurice |  |  |  |
| 7541 | 2393.2.2 | Stage 3 - impacts MLP and RLP |  | 250d? | 2004-01-01 A | 2004-12-15 A | 100% | 2004-01-01 | 2004-12-15 | 250d? | finish no earlier than 2004-12-15 | OMA | 2000h | 2000h | OMA | OMA-LIAISON@mail.openmobilealliance.org | Rel-6 |  |  |  |  |
| 7542 | 12.3 | **Enhanced inter-GMLC interface** |  | 648d? | 2002-06-24 A | 2004-12-15 A | 100% | 2002-06-24 | 2004-12-15 | 648d? |  | S2; OMA | 14888h | 14888h | Nokia | Jan Kåll | Rel-6 | Maurice |  |  |  |
| 7543 | 2393.3.1 | Stage 2 for Enhanced inter-GMLC interface |  | 315d? | 2002-06-24 A | 2003-09-05 A | 100% | 2002-06-24 | 2003-09-05 | 315d? | finish no earlier than 2003-09-05 | S2 | 2520h | 2520h | Nokia | Jan Kåll | Rel-6 | Maurice |  |  |  |
| 7544 | 2393.3.2 | Stage 3 - definition of RLP and PCP |  | 250d? | 2004-01-01 A | 2004-12-15 A | 100% | 2004-01-01 | 2004-12-15 | 250d? | finish no earlier than 2004-12-15 | OMA | 2000h | 2000h | OMA | OMA-LIAISON@mail.openmobilealliance.org | Rel-6 |  |  |  |  |
| 7545 | 12.4 | **Location Services support for IMS public identities** |  | 473d? | 2003-02-24 A | 2004-12-15 A | 100% | 2003-02-24 | 2004-12-15 | 473d? |  | S2; OMA | 11488h | 11488h | Nokia | Jan Kåll | Rel-6 | Maurice |  |  |  |
| 7546 | 2393.4.1 | Stage 2 for Location Services support for IMS public identities |  | 240d? | 2003-02-24 A | 2004-01-23 A | 100% | 2003-02-24 | 2004-01-23 | 240d? | finish no earlier than 2004-01-23 | S2 | 1920h | 1920h | Nokia | Jan Kåll | Rel-6 | Maurice |  |  |  |
| 7547 | 2393.4.2 | OMA Stage 3 for Location Services support for IMS public identities - impacts MLP, RLP and PCP |  | 250d? | 2004-01-01 A | 2004-12-15 A | 100% | 2004-01-01 | 2004-12-15 | 250d? | finish no earlier than 2004-12-15 | OMA | 2000h | 2000h | OMA | OMA-LIAISON@mail.openmobilealliance.org | Rel-6 |  |  |  |  |
| 7548 | 12.5 | **New area event for location service triggering reports** |  | 663d? | 2002-06-03 A | 2004-12-15 A | 100% | 2002-06-03 | 2004-12-15 | 663d? |  | S2; N4; OMA | 22024h | 22024h | Nokia | Jan Kåll | Rel-6 | Maurice |  |  |  |
| 7549 | 2393.5.1 | Stage 2 for New area event for location service triggering reports |  | 280d? | 2002-06-03 A | 2003-06-27 A | 100% | 2002-06-03 | 2003-06-27 | 280d? | finish no earlier than 2003-06-27 | S2 | 2240h | 2240h | Nokia | Jan Kåll | Rel-6 | Maurice |  |  |  |
| 7550 | 2393.5.2 | Stage 3 for UE-CN signalling |  | 234d? | 2003-10-09 A | 2004-08-31 A | 100% | 2003-10-09 | 2004-08-31 | 234d? | start no earlier than 2003-10-09 | N4 | 1872h | 1872h | Nokia |  | Rel-6 | Kimmo |  |  |  |
| 7551 | 2393.5.3 | Stage 3 for New area event for location service triggering reports - impacts MLP, RLP and PCP |  | 250d? | 2004-01-01 A | 2004-12-15 A | 100% | 2004-01-01 | 2004-12-15 | 250d? | finish no earlier than 2004-12-15 | OMA | 2000h | 2000h | OMA | OMA-LIAISON@mail.openmobilealliance.org | Rel-6 |  |  |  |  |
| 7552 | 12.7 | **UE positioning for Location Services enhancements 2** |  | 957d? | 2001-01-15 A | 2004-09-14 A | 100% | 2001-01-15 | 2004-09-14 | 957d? |  | R2; R4; R5 | 36456h | 36456h |  |  | Rel-6 | Issam | LCS2-UEpos | LCS2-UEpos |  |
| 7553 | 12.8 | Open SMLC-SRNC Interface within the UTRAN to support UTRAN Rel-4 positioning methods |  | 700d? | 2001-01-15 A | 2003-09-19 A | 100% | 2001-01-15 | 2003-09-19 | 700d? | finish no earlier than 2003-09-19 | R2 | 5600h | 5600h | Siemens | Meik.Kottkamp@siemens.com | Rel-6 | Yong-Jun | LCS-Rel4Pos | LCS-Rel4Pos |  |
| 7554 | 2393.6.2 | A-GPS minimum performance specification |  | 333d? | 2003-06-06 A | 2004-09-14 A | 100% | 2003-06-06 | 2004-09-14 | 333d? | finish no earlier than 2004-09-14 | R4; R5 | 5328h | 5328h | AT&T Wireless | donglin.shen@attws.com | Rel-6 | Issam | LCS-UEPos-AGPSPerf | LCS-UEPos-AGPSPerf |  |
| 7555 | 12.7.2 | Deleted - FS on Enhancements to OTDOA Positioning using advanced blanking methods |  | 320d | 2002-07-01 A | 2003-09-19 A | 100% | 2002-07-01 | 2003-09-19 | 320d | finish no earlier than 2003-09-19 | R2 | 2560h | 2560h | Cambridge Positioning Systems | david.bartlett@cursor-system.com | Rel-6 | Yong-Jun | LCS2-UEpos-FSBlank | LCS2-UEpos-FSBlank | RP-38 |
| 7556 | 2393.6.4 | Deleted - UE positioning enhancements - other methods | milestone | 0d? | 2003-09-26 A | 2003-09-26 A | 100% | 2003-09-26 | 2003-09-26 | 0d? | finish no earlier than 2003-09-26 | R2 |  |  | Siemens | Meik.Kottkamp@siemens.com | Rel-6 | Yong-Jun | LCS2-UEpos-enh | LCS2-UEpos-enh | RP-24 |
| 7557 | 2393.7 | LCS charging |  | 455d? | 2003-03-21 A | 2004-12-16 A | 100% | 2003-03-21 | 2004-12-16 | 455d? | start no earlier than 2003-03-21 | S5 | 3640h | 3640h | France Telecom | alain.bibas@orange-ft.com | Rel-6 | Mirko | LCS2-CH | LCS2-CH |  |
| 7558 | 14 | **Rel-6 Security enhancements** |  | 1018d? | 2001-01-03 A | 2004-11-26 A | 100% | 2001-01-03 | 2004-11-26 | 1018d? |  | S3 | 28824h | 28824h | Vodafone | Peter.Howard@vodafone.com | Rel-6 | Mirko | SEC16 | SEC1, Rel-6 |  |
| 7559 | 14.1 | **Enhanced HE control of security (including positive authentication reporting)** |  | 712d | 2001-01-03 A | 2003-09-25 A | 100% | 2001-01-03 | 2003-09-25 | 712d |  | S3 | 14064h | 14064h | Vodafone | Peter.Howard@vodafone.com | Rel-6 | Mirko |  |  |  |
| 7560 | 14.1.1 | Deleted - SEC1 Stage 2 (Enhanced HE control of security) |  | 378d | 2001-01-03 A | 2002-06-14 A | 100% | 2001-01-03 | 2002-06-14 | 378d | finish no earlier than 2002-06-14 | S3 | 3024h | 3024h |  |  | Rel-6 | Mirko |  |  | SP-16 |
| 7561 | 14.1.3 | **Rel-6 Network Domain Security** |  | 334d | 2002-06-17 A | 2003-09-25 A | 100% | 2002-06-17 | 2003-09-25 | 334d |  | S3 | 5344h | 5344h | Telenor | Geir-myrdahl.koien@telenor.com | Rel-6 | Mirko | SEC1-NDS | SEC1-NDS |  |
| 7562 | 14.1.3.1 | Rel-6 IP network layer security (NDS/IP) |  | 334d | 2002-06-17 A | 2003-09-25 A | 100% | 2002-06-17 | 2003-09-25 | 334d | finish no earlier than 2003-09-25 | S3 | 2672h | 2672h |  |  | Rel-6 | Mirko | SEC1-NDS-IP | SEC1-NDS-IP |  |
| 7563 | 2394.2 | Network Domain Security; Authentication Framework (NDS/AF) |  | 521d? | 2002-02-15 A | 2004-02-13 A | 100% | 2002-02-15 | 2004-02-13 | 521d? | finish no earlier than 2004-02-13 | S3 | 4168h | 4168h | Nokia | tommi.viitanen@nokia.com | Rel-6 | Mirko | SEC1-NDS-AF | SEC1-NDS-AF |  |
| 7564 | 2394.3 | Key Management of group keys for Voice Group Call Services |  | 306d | 2003-09-26 A | 2004-11-26 A | 100% | 2003-09-26 | 2004-11-26 | 306d | finish no earlier than 2004-11-26 | S3 | 2448h | 2448h | Vodafone | benno.tietz@vodafone.com | Rel-6 | Mirko | SECGKYV | SECGKYV |  |
| 7565 | 2395 | Network Domain Security; MAP application layer security (NDS/MAPsec) |  | 127d? | 2004-07-06 A | 2004-12-29 A | 100% | 2004-07-06 | 2004-12-29 | 127d? | finish no earlier than 2003-12-26 | S3 | 1016h | 1016h | Vodafone | Peter.Howard@vodafone.com | Rel-6 | Mirko | MAPSEC | MAPSEC |  |

Notes:
- 7539: -
- 7540: - / Impacted TSs and TRs: 23.002.23.271
- 7541: -
- 7542: -
- 7543: - / Impacted TSs and TRs: 23.002.23.271
- 7544: -
- 7545: -
- 7546: - / Impacted TSs and TRs: 23.002.23.271
- 7547: -
- 7548: -
- 7549: - / Impacted TSs and TRs: 23.002.23.271
- 7550: Current stage 3 fullfills stage 2
- 7551: -
- 7552: -
- 7553: - / Impacted TSs and TRs: 25.305; 25.401; 25.450; 25.452; 25.453
- 7554: RP#25 completed (FDD) / Impacted TSs and TRs: new 25.171; 34.171 (testing)
- 7555: RP#38 Work stopped / Impacted TSs and TRs: new 25.894
- 7556: RP#24 Work stopped
- 7557: SP#26 completed / Impacted TSs and TRs: new 32.271
- 7558: SP#9 approved WID. Acronym changed from "SEC1, Rel-6"
- 7559: SP#9 approved WID S3-000490 (Enhanced home control of security by HE) / Impacted TSs and TRs: 33.102
- 7560: Marked as stopped 12/2008
- 7561: SP#9 approved WID S3-000606 (Network Domain Security) / Impacted TSs and TRs: 33.102; 33.103; 33.105
- 7562: SP#9 approved WID S3-000626 (Access security for IP-based services) / Impacted TSs and TRs: 33.210
- 7563: SP#19 approved WID / Impacted TSs and TRs: 33.810
- 7564: - / Impacted TSs and TRs: 42.068; 43.068; 44.068; 42.069; 43.069; 44.069; 31.102; 24.008; 48.008; 42.009; 43.020; New TSs (55.236; 55.205) MILENAGE algorithms
- 7565: SP#19 approved WID. Marked as closed 12/2008 (was marked 20% complete) / Impacted TSs and TRs: 33.200

| ID | WBS | Task | Type | Duration | Start | Finish | Complete | Baseline start | Baseline finish | Baseline duration | Constraint | Resources | Work | Actual work | Acronym | Release | MCC resp | Acronym_3GU_Export | Impacted TSs and TRs | WI rapporteur name | WI rapporteur e-mail | TSG stopped |
| --- | --- | --- | --- | --- | --- | --- | --- | --- | --- | --- | --- | --- | --- | --- | --- | --- | --- | --- | --- | --- | --- | --- |
| 7566 | 16 | **IMS Phase 2** |  | 1840d? | 2000-08-28 A | 2007-09-14 A | 100% | 2000-08-28 | 2007-09-14 | 1840d? |  | S1; S2; S3; S5; NP; R5 | 210576h | 210576h | IMS2 | Rel-6 | Alain | IMS2 |  |  |  |  |
| 7567 | 2396.1 | Enhancements to the Cx and Sh interfaces |  | 323d? | 2003-06-06 A | 2004-08-31 A | 100% | 2003-06-06 | 2004-08-31 | 323d? | finish no earlier than 2004-08-31 | N4 | 2584h | 2584h | IMS2-CCR | Rel-6 | Kimmo | IMS2-CCR |  |  |  |  |
| 7568 | 2396.2 | Conformance Test Aspects – IMS Call Control Rel-6 enhancements |  | 396d? | 2006-03-10 A | 2007-09-14 A | 100% | 2006-03-10 | 2007-09-14 | 396d? | finish no earlier than 2007-09-14 | R5 | 3168h | 3168h | IMS2_CCR_Test | Rel-6 | Ingbert | IMS2_CCR_Test | 34.229-1; 34.229-2; 34.229-3; 34.108 | Ericsson | Jacob.John@motorola.com, Leif.Mattisson@ericsson.com |  |
| 7569 | 16.12 | **IMS Group Management** |  | 715d? | 2002-03-14 A | 2004-12-08 A | 100% | 2002-03-14 | 2004-12-08 | 715d? |  | S1 | 12680h | 12680h | IMSGM | Rel-6 | Alain | IMSGM |  | Nokia | juha.kalliokulju@nokia.com |  |
| 7570 | 16.12.1 | Stage 1 - TS on IMS group management |  | 193d | 2002-03-14 A | 2002-12-09 A | 100% | 2002-03-14 | 2002-12-09 | 193d | finish no earlier than 2002-12-09 | S1 | 1544h | 1544h |  | Rel-6 | Alain |  |  | Nokia | juha.kalliokulju@nokia.com |  |
| 7571 | 2396.3.2 | Stage 2 for IMS Group Management |  | 158d? | 2003-05-26 A | 2003-12-31 A | 100% | 2003-05-26 | 2003-12-31 | 158d? | finish no earlier than 2003-12-31 | S2 | 1264h | 1264h |  | Rel-6 | Maurice |  | 23.228 |  |  |  |
| 7572 | 2396.3.3 | Stage 3 for IMS Group management (e.g. chat) |  | 519d? | 2002-12-13 A | 2004-12-08 A | 100% | 2002-12-13 | 2004-12-08 | 519d? | finish no earlier than 2004-12-08 | N1 | 4152h | 4152h |  | Rel-6 | Frederic |  |  | Lucent | Keith Drage (drage@alcatel-lucent.com) |  |
| 7573 | 2396.4 | **IMS Conferencing** |  | 548d? | 2002-11-04 A | 2004-12-08 A | 100% | 2002-11-04 | 2004-12-08 | 548d? |  | N1 | 10960h | 10960h |  | Rel-6 | Frederic |  |  |  |  |  |
| 7574 | 2396.4.1 | Stage 2 for IMS Conferencing |  | 303d? | 2002-11-04 A | 2003-12-31 A | 100% | 2002-11-04 | 2003-12-31 | 303d? | finish no earlier than 2003-12-31 | S2 | 2424h | 2424h |  | Rel-6 | Maurice |  | 23.228 |  |  |  |
| 7575 | 2396.4.2 | Stage 3 for IMS Conferencing |  | 519d? | 2002-12-13 A | 2004-12-08 A | 100% | 2002-12-13 | 2004-12-08 | 519d? | finish no earlier than 2004-12-08 | N1 | 4152h | 4152h |  | Rel-6 | Frederic |  |  | Lucent | Keith Drage (drage@alcatel-lucent.com) |  |
| 7576 | 16.11 | **IMS Messaging** |  | 992d? | 2002-03-14 A | 2005-12-30 A | 100% | 2002-03-14 | 2005-12-30 | 992d? |  | S1 | 23912h | 23912h | IMSM | Rel-6 | Alain | IMSM |  | Nokia | juha.kalliokulju@nokia.com |  |
| 7577 | 16.11.1 | TR on support of messaging in the IMS |  | 193d | 2002-03-14 A | 2002-12-09 A | 100% | 2002-03-14 | 2002-12-09 | 193d | finish no earlier than 2002-12-09 | S1 | 1544h | 1544h | IMSM-TR | Rel-6 | Alain | IMSM-TR | New 22.940 | Nokia | juha.kalliokulju@nokia.com |  |
| 7578 | 2396.5.2 | Stage 1 22.340 |  | 23d? | 2002-11-11 A | 2002-12-11 A | 100% | 2002-11-11 | 2002-12-11 | 23d? | finish no earlier than 2002-12-11 | S1 | 184h | 184h | IMSM-TS | Rel-6 | Alain | IMSM-TS | 22.340 | Nokia | juha.kalliokulju@nokia.com |  |
| 7579 | 2396.5.3 | CRs to 22.140 & 22.228 |  | 263d? | 2002-03-14 A | 2003-03-17 A | 100% | 2002-03-14 | 2003-03-17 | 263d? | finish no earlier than 2003-03-17 | S1 | 2104h | 2104h | IMSM-CR | Rel-6 | Alain | IMSM-CR | 22.140.22.228 | Nokia | juha.kalliokulju@nokia.com |  |
| 7580 | 16.11.3 | Stage 2 for IMS Messaging |  | 477d | 2002-11-04 A | 2004-08-31 A | 100% | 2002-11-04 | 2004-08-31 | 477d | finish no earlier than 2004-08-31 | S2 | 3816h | 3816h |  | Rel-6 | Maurice |  | 23.228 |  |  |  |
| 7581 | 2396.5.5 | Stage 3 for IMS Messaging |  | 519d? | 2002-12-13 A | 2004-12-08 A | 100% | 2002-12-13 | 2004-12-08 | 519d? | finish no earlier than 2004-12-08 | N1 | 4152h | 4152h |  | Rel-6 | Frederic |  |  | Lucent | Keith Drage (drage@alcatel-lucent.com) |  |
| 7582 | 2396.5.6 | SIP/SIMPLE Instant messaging |  | 522d? | 2004-01-01 A | 2005-12-30 A | 100% | 2004-01-01 | 2005-12-30 | 522d? | finish no earlier than 2005-06-30 | OMA | 4176h | 4176h |  | Rel-6 |  |  |  |  | OMA-LIAISON@mail.openmobilealliance.org |  |
| 7583 | 2396.6 | **Additional SIP Capabilities support not covered by Rel-5** |  | 680d? | 2002-11-11 A | 2005-06-17 A | 100% | 2002-11-11 | 2005-06-17 | 680d? |  | N1 | 13392h | 13392h |  | Rel-6 | Frederic |  |  |  |  |  |
| 7584 | 2396.6.1 | Stage 2 for add SIP cap (e.g. forking) |  | 335d? | 2002-11-11 A | 2004-02-20 A | 100% | 2002-11-11 | 2004-02-20 | 335d? | finish no earlier than 2004-02-20 | S2 | 2680h | 2680h |  | Rel-6 | Maurice |  | 23.228 |  |  |  |
| 7585 | 2396.6.2 | Stage 3 for Additional SIP Capabilities |  | 454d? | 2002-12-13 A | 2004-09-08 A | 100% | 2002-12-13 | 2004-09-08 | 454d? | finish no earlier than 2004-09-08 | N1 | 3632h | 3632h |  | Rel-6 | Frederic |  |  | Lucent | Keith Drage (drage@alcatel-lucent.com) |  |
| 7586 | 2396.6.3 | Procedured associated with IMS-ALG |  | 205d? | 2004-09-06 A | 2005-06-17 A | 100% | 2004-09-06 | 2005-06-17 | 205d? | start no earlier than 2004-09-06 | N1 | 1640h | 1640h |  | Rel-6 | Frederic |  |  |  |  |  |
| 7587 | 2396.7 | Review additional SIP Capabilities against IMS |  | 454d? | 2002-12-13 A | 2004-09-08 A | 100% | 2002-12-13 | 2004-09-08 | 454d? | finish no earlier than 2004-09-08 | N1 | 3632h | 3632h |  | Rel-6 | Frederic |  |  | Lucent | Keith Drage (drage@alcatel-lucent.com) |  |
| 7588 | 16.5 | **Interworking between IMS and IP networks** |  | 1118d? | 2000-08-28 A | 2004-12-08 A | 100% | 2000-08-28 | 2004-12-08 | 1118d? |  | N3 | 31712h | 31712h | IMS-CCR-IWIP | Rel-6 | Gwiho | IMS-CCR-IWIP | 23.821; 29.061; 29.162 | BT | nigel.holland@bt.com |  |
| 7589 | 16.5.1 | Interworking for 3GPP_SIP and IETF_SIP |  | 730d | 2000-08-28 A | 2003-06-13 A | 100% | 2000-08-28 | 2003-06-13 | 730d | finish no earlier than 2003-06-13 | N3 | 5840h | 5840h |  | Rel-6 | Gwiho |  | New 29.962 | Siemens | Thomas.Belling@nsn.com |  |
| 7590 | 16.5.2 | Interworking for IPv6 to IPv4 |  | 1118d | 2000-08-28 A | 2004-12-08 A | 100% | 2000-08-28 | 2004-12-08 | 1118d | finish no earlier than 2004-12-08 | N3 | 8944h | 8944h |  | Rel-6 | Gwiho |  | 29.163 |  |  |  |
| 7591 | 2396.8.3 | Interworking for IPv6 to IPv4 (SIP / SDP aspects) |  | 87d? | 2004-05-11 A | 2004-09-08 A | 100% | 2004-05-11 | 2004-09-08 | 87d? | finish no earlier than 2004-09-08 | N1 | 696h | 696h |  | Rel-6 | Frederic |  |  |  |  |  |
| 7592 | 16.8.1 | stage 3 of interworking with non-IMS IP networks |  | 911d | 2001-03-14 A | 2004-09-08 A | 100% | 2001-03-14 | 2004-09-08 | 911d | finish no earlier than 2004-09-08 | N1 | 7288h | 7288h |  | Rel-6 | Frederic |  |  |  |  |  |
| 7593 | 16.6.1 | Interworking between IMS and CS networks |  | 929d? | 2000-08-28 A | 2004-03-18 A | 100% | 2000-08-28 | 2004-03-18 | 929d? | finish no earlier than 2004-03-18 | N3 | 7432h | 7432h | IMS-CCR-IWCS | Rel-6 | Gwiho | IMS-CCR-IWCS | 29.163; 29.061; 24.228; and New CN4 specification | Vodafone | Brendan.McWilliams@gb.vodafone.co.uk |  |
| 7594 | 16.10 | Mn interface (IM-MGW to MGCF) enhancements (CN4 Part) |  | 418d | 2001-08-07 A | 2004-09-01 A | 100% | 2001-08-07 | 2004-09-01 | 418d | finish no earlier than 2004-09-01 | N4 | 3344h | 3344h | IMS-CCR-Mn | Rel-6 | Kimmo | IMS-CCR-Mn |  |  |  |  |
| 7595 | 2396.11 | Study of subscriber and operators relationship in IMS and related ISIM requirements for Rel 6” |  | 20d? | 2002-11-15 A | 2002-12-12 A | 100% | 2002-11-15 | 2002-12-12 | 20d? | finish no earlier than 2002-12-12 | S1 | 160h | 160h |  | Rel-6 | Alain |  |  | Nokia | juha.kalliokulju@nokia.com |  |
| 7596 | 2396.12 | Lawful Interception in Rel-6 architecture |  | 269d? | 2002-12-09 A | 2003-12-18 A | 100% | 2002-12-09 | 2003-12-18 | 269d? | finish no earlier than 2003-12-18 | S3 | 2152h | 2152h | SEC1-LI | Rel-6 | Mirko | SEC1-LI, Rel-6 | 33.106; 33.107; 33.108 | Reg TP, Nortel | berthold.wilhelm@regtp.de, Ron Ryan |  |
| 7597 | 2396.13 | IMS Subscription and access scenarios |  | 130d? | 2002-12-16 A | 2003-06-13 A | 100% | 2002-12-16 | 2003-06-13 | 130d? | start no earlier than 2002-12-16 | S1 | 1040h | 1040h |  | Rel-6 | Alain |  | 22.800 | TeliaSonera | FRANK, Robert |  |
| 7598 | 2396.14 | IMS charging |  | 455d? | 2003-03-21 A | 2004-12-16 A | 100% | 2003-03-21 | 2004-12-16 | 455d? | finish no earlier than 2004-12-16 | S5 | 3640h | 3640h | IMS2-CH | Rel-6 | Mirko | IMS2-CH | 32.260 | Ericsson | Patrik TEPPO |  |
| 7599 | 2396.15 | IMS Management objects |  | 306d? | 2004-09-03 A | 2005-11-04 A | 100% | 2004-09-03 | 2005-11-04 | 306d? | finish no earlier than 2005-03-04 | N1 | 2448h | 2448h |  | Rel-6 | Frederic |  | 24.167 |  |  |  |
| 7600 | 2396.16 | Deleted - Stage 2 of IMS Phase 2 | milestone | 0d? | 2003-09-19 A | 2003-09-19 A | 100% | 2003-09-19 | 2003-09-19 | 0d? | finish no earlier than 2003-09-19 | S2 |  |  |  | Rel-6 | Maurice |  |  |  |  | SP-21 |

Notes:
- 7566: -
- 7567: Shared public user identities need to be solved. If email approval CR is accepted. Work 100% done.
- 7568: -
- 7569: -
- 7570: -
- 7571: -
- 7572: Depends on CN decision on CPCP in Rel-6. Complete, if unresolved IETF dependencies are dropped (-> LS to CN plenary)
- 7573: -
- 7574: -
- 7575: Depends on CN decision on IETF dependenciES in CP-150Rel-6. Higher figure if CPCP is dropped (-> LS to CN plenary)
- 7576: -
- 7577: -
- 7578: -
- 7579: -
- 7580: -
- 7581: -
- 7582: Updated according to SP-040232
- 7583: -
- 7584: -
- 7585: -
- 7586: -
- 7587: -
- 7588: [DAB 14.02.02] - end date pushed back to March 2003
- 7589: [DAB - 20.08.03] - CN Part of TR Complete @ CN#20
- 7590: -
- 7591: -
- 7592: -
- 7593: [DAB - 25.05.04] - CN3 consider this work to be complete
- 7594: TISPAN issue is open
- 7595: -
- 7596: Acronym changed from "SEC1-LI, Rel6"
- 7597: -
- 7598: SP#26 12/2004 completed
- 7599: -
- 7600: -

| ID | WBS | Task | Type | Duration | Start | Finish | Complete | Baseline start | Baseline finish | Baseline duration | Constraint | Resources | Work | Actual work | Acronym | WI rapporteur name | WI rapporteur e-mail | Release | MCC resp | Acronym_3GU_Export | Impacted TSs and TRs | Created at | TSG stopped |
| --- | --- | --- | --- | --- | --- | --- | --- | --- | --- | --- | --- | --- | --- | --- | --- | --- | --- | --- | --- | --- | --- | --- | --- |
| 7601 | 2397 | **3GPP Enablers for services like Push to Talk over Cellular (PoC)** |  | 459d? | 2003-09-08 A | 2005-06-09 A | 100% | 2003-09-08 | 2005-06-09 | 459d? |  | S2; S4; S5 | 18040h | 18040h | PoC | Ericsson | Shabnam Sultana | Rel-6 | Maurice | PoC |  |  |  |
| 7602 | 2397.1 | Feasibility Study on 3GPP Enablers for services like Push to Talk over Cellular (PoC) |  | 322d? | 2003-09-08 A | 2004-11-30 A | 100% | 2003-09-08 | 2004-11-30 | 322d? | finish no earlier than 2004-11-30 | S2 | 2576h | 2576h |  | Ericsson | Shabnam Sultana | Rel-6 | Maurice |  | 23.979 | SP-24 |  |
| 7603 | 2397.2 | Dependencies on OMA PoC |  | 303d? | 2004-01-01 A | 2005-02-28 A | 100% | 2004-01-01 | 2005-02-28 | 303d? | finish no earlier than 2004-12-30 | OMA | 2424h | 2424h |  |  | OMA-LIAISON@mail.openmobilealliance.org | Rel-6 |  |  |  | SP-24 |  |
| 7604 | 2397.3 | Selection of one or more PoC codec(s) for PoC |  | 69d? | 2004-09-13 A | 2004-12-16 A | 100% | 2004-09-13 | 2004-12-16 | 69d? | start no earlier than 2004-09-13 | S4 | 552h | 552h |  |  |  | Rel-6 | Paolo |  | 26.235; 26.236 | SP-25 |  |
| 7605 | 2397.4 | PoC charging |  | 184d? | 2004-09-27 A | 2005-06-09 A | 100% | 2004-09-27 | 2005-06-09 | 184d? | finish no earlier than 2005-06-09 | S5 | 1472h | 1472h | PoC-CH | Siemens | Gerald.Goermer@nsn.com | Rel-6 | Mirko | PoC-CH | 32.272 |  |  |
| 7606 | 2398 | Study on Interworking aspects and migration scenarios for IPv4 based IMS Implementations |  | 210d? | 2003-09-08 A | 2004-06-25 A | 100% | 2003-09-08 | 2004-06-25 | 210d? | finish no earlier than 2004-06-25 | S2 | 1680h | 1680h | IPv4IMS | Siemens | Alexander Milinski | Rel-6 | Maurice | IPv4IMS | 23.981 |  |  |
| 7607 | 16.3 | **Interoperability and Commonality between IMS using different IP-connectivity Networks** |  | 325d? | 2002-09-16 A | 2003-12-12 A | 100% | 2002-09-16 | 2003-12-12 | 325d? |  | S2 | 9176h | 9176h | IMSCOOP |  |  | Rel-6 | Maurice | IMSCOOP | 23.864 |  |  |
| 7608 | 16.3.1 | Stage 2 for Interoperability |  | 272d | 2002-09-16 A | 2003-09-30 A | 100% | 2002-09-16 | 2003-09-30 | 272d | finish no earlier than 2003-09-30 | S2 | 2176h | 2176h |  | Nokia | balazs.bertenyi@nsn.com | Rel-6 | Maurice |  | 23.864 |  |  |
| 7609 | 2399.2 | Stage 2 for commonality |  | 265d? | 2002-09-16 A | 2003-09-19 A | 100% | 2002-09-16 | 2003-09-19 | 265d? | start no earlier than 2002-09-16 | S2 | 2120h | 2120h |  | Nokia | balazs.bertenyi@nsn.com | Rel-6 | Maurice |  | 23.864 |  |  |
| 7610 | 16.3.2 | Stage 3 for Interoperability and Commonality between IMS using different IP-connectivity Networks |  | 305d | 2002-10-14 A | 2003-12-12 A | 100% | 2002-10-14 | 2003-12-12 | 305d | finish no earlier than 2003-12-12 | N1 | 2440h | 2440h |  | Lucent | Keith Drage (drage@alcatel-lucent.com) | Rel-6 | Frederic |  |  |  |  |
| 7611 | 17 | **Support of Push Services** |  | 823d | 2001-01-03 A | 2004-02-27 A | 100% | 2001-01-03 | 2004-02-27 | 823d |  | S1 | 11390.6h | 11390.6h | PUSH | NTT Comware | Yoshinori Kitada | Rel-6 | Alain | PUSH | 23.976 |  |  |
| 7612 | 17.1 | Stage 1 for Support of Push Services |  | 378d | 2001-01-03 A | 2002-06-14 A | 100% | 2001-01-03 | 2002-06-14 | 378d | finish no earlier than 2002-06-14 | S1 | 3024h | 3024h |  |  |  | Rel-6 | Alain |  |  |  |  |
| 7613 | 17.3 | TR 23.976 on Push Architecture |  | 340d | 2002-11-11 A | 2004-02-27 A | 100% | 2002-11-11 | 2004-02-27 | 340d | finish no earlier than 2004-02-27 | S2 | 2720h | 2720h |  | Research In Motion | Nick Alfano | Rel-6 | Maurice |  | 23.976 |  |  |
| 7614 | 18 | **Rel-6 Multimedia Messaging (MMS) enhancements** |  | 865d? | 2002-08-15 A | 2005-12-07 A | 100% | 2002-08-15 | 2005-12-07 | 865d? |  | T2; S1; S4; S5; OMA | 59616h | 59616h | MMS6 | Siemens | Josef.Laumen@SAL.SIEMENS.DE | Rel-6 | Kimmo | MMS6 |  |  |  |
| 7615 | 18.1 | **Definition of service requirements for MMS6** |  | 286d? | 2002-11-15 A | 2003-12-19 A | 100% | 2002-11-15 | 2003-12-19 | 286d? |  | S1 | 4576h | 4576h | MMS6-SR |  |  | Rel-6 | Alain | MMS6-SR | 22.140 |  |  |
| 7616 | 2401.1.1 | Definition of service requirements charging |  | 286d? | 2002-11-15 A | 2003-12-19 A | 100% | 2002-11-15 | 2003-12-19 | 286d? | finish no earlier than 2003-12-20 | S1 | 2288h | 2288h |  | Siemens | Josef.Laumen@SAL.SIEMENS.DE | Rel-6 | Alain |  | 22.140 |  |  |
| 7617 | 18.2 | Technical realization of MMS6 |  | 591d | 2002-09-06 A | 2004-12-10 A | 100% | 2002-09-06 | 2004-12-10 | 591d | finish no earlier than 2004-12-10 | T2 | 4728h | 4728h |  | Siemens | Josef.Laumen@SAL.SIEMENS.DE | Rel-6 | Kimmo |  | 23.140 |  |  |
| 7618 | 18.3 | OMA dependencies |  | 446d | 2003-08-15 A | 2005-04-29 A | 100% | 2003-08-15 | 2005-04-29 | 446d | finish no earlier than 2004-12-10 | OMA | 3568h | 3568h |  |  |  | Rel-6 | Kimmo |  | OMA specs |  |  |
| 7619 | 18.4 | MMS formats and codecs for MMS6 |  | 865d | 2002-08-15 A | 2005-12-07 A | 100% | 2002-08-15 | 2005-12-07 | 865d | finish no earlier than 2005-12-07 | S4 | 6920h | 6920h | MMS6-Codec | Nokia | roberto.castagno@nokia.com | Rel-6 | Paolo | MMS6-Codec | 26.140; 26.936 |  |  |
| 7620 | 2401.5 | Handling of private addressing schemes in MMS |  | 263d | 2003-12-10 A | 2004-12-10 A | 100% | 2003-12-10 | 2004-12-10 | 263d | finish no earlier than 2004-12-10 | T2 | 2104h | 2104h |  | T-Mobile | Steffen.Habermann@T-MOBILE.DE | Rel-6 | Kimmo |  | 23.140 |  |  |
| 7621 | 2401.6 | MMS charging |  | 390d? | 2003-03-21 A | 2004-09-16 A | 100% | 2003-03-21 | 2004-09-16 | 390d? | start no earlier than 2003-03-21 | S5 | 3120h | 3120h | MMS6-CH |  |  | Rel-6 | Mirko | MMS6-CH | 32.270 |  |  |
| 7622 | 2401.7 | Deleted - FS Multiple MMS Relay/Server Architecture | milestone | 0d | 2004-12-10 A | 2004-12-10 A | 100% | 2004-12-10 | 2004-12-10 | 0d | finish no earlier than 2004-12-10 | T2 |  |  |  | Telefónica Móviles | Juan Gorospe (gorospe_j@tsm.es) | Rel-6 | Kimmo |  | probably Annex to 23.140 |  | TP-26 |
| 7623 | 19 | **Rel-6 MExE enhancements** |  | 326d | 2002-03-08 A | 2003-06-06 A | 100% | 2002-03-08 | 2003-06-06 | 326d |  | T2 | 7328h | 7328h | MEXE6 |  |  | Rel-6 | Kimmo | MEXE6 |  |  |  |
| 7624 | 19.1 | MExE Rel-6 Improvements and Investigations |  | 264d | 2002-03-08 A | 2003-03-12 A | 100% | 2002-03-08 | 2003-03-12 | 264d | finish no earlier than 2003-03-12 | T2 | 2112h | 2112h | MEXE6-ENHANC | TTPCom | Lars Brenk ( (lsb_ttpcom@HOTMAIL.COM) | Rel-6 | Kimmo | MEXE6-ENHANC |  |  |  |
| 7625 | 19.2 | MExE Run-Time Independent Framework Feasibility Study |  | 326d | 2002-03-08 A | 2003-06-06 A | 100% | 2002-03-08 | 2003-06-06 | 326d | finish no earlier than 2003-06-06 | T2 | 2608h | 2608h | MEXE6-RTIF | Nokia Siemens Networks | balazs.bertenyi@nokia.com | Rel-6 | Kimmo | MEXE6-RTIF | 22.857 |  |  |
| 7626 | 21 | Subscription Management |  | 650d | 2002-09-20 A | 2005-03-17 A | 100% | 2002-09-20 | 2005-03-17 | 650d | finish no earlier than 2005-03-17 | S5 | 5200h | 5200h | SuM | T-Mobile | istvan.aba@t-mobile.at | Rel-6 | Mirko | SuM | 32.140/1; 32.171/2/5; 32.803 |  |  |

Notes:
- 7601: -
- 7602: -
- 7603: Updated according to SP-040232
- 7604: Completed
- 7605: SP#28 06/2005 completed
- 7606: -
- 7607: -
- 7608: No contributions assumed that no more will be done in 3GPP hence work may need to be done in 3GPP2
- 7609: -
- 7610: -
- 7611: Changed from FS to actual support of Push
- 7612: -
- 7613: -
- 7614: -
- 7615: -
- 7616: -
- 7617: -
- 7618: -
- 7619: -
- 7620: -
- 7621: SP#25 09/2004 completed
- 7622: originally it was intended to create a FS TR but most likely the work will become an Annex of 23.140
- 7623: -
- 7624: -
- 7625: -
- 7626: SP#27 03/2005 completed

| ID | WBS | Task | Duration | Start | Finish | Complete | Baseline start | Baseline finish | Baseline duration | Constraint | Resources | Work | Actual work | Acronym | WI rapporteur name | WI rapporteur e-mail | Release | MCC resp | Acronym_3GU_Export |
| --- | --- | --- | --- | --- | --- | --- | --- | --- | --- | --- | --- | --- | --- | --- | --- | --- | --- | --- | --- |
| 7627 | 22 | **Presence Capability** | 1233d? | 2001-03-19 A | 2005-12-07 A | 100% | 2001-03-19 | 2005-12-07 | 1233d? |  | S1; S2; S3; S4; N1; N3; N4; OMA | 111784h | 111784h | PRESNC | Motorola | Mark Cataldo | Rel-6 | Alain | PRESNC |
| 7628 | 22.1 | Stage 1 for Presence Capability | 610d | 2001-03-19 A | 2003-07-18 A | 100% | 2001-03-19 | 2003-07-18 | 610d | finish no earlier than 2003-07-18 | S1 | 4880h | 4880h |  | Motorola | Mark Cataldo | Rel-6 | Alain |  |
| 7629 | 22.2 | Stage 2 for Presence Capability | 268d | 2001-09-12 A | 2002-09-20 A | 100% | 2001-09-12 | 2002-09-20 | 268d | finish no earlier than 2002-09-20 | S2 | 2144h | 2144h |  | Nokia | balazs.bertenyi@nsn.com | Rel-6 | Maurice |  |
| 7630 | 22.3 | Stage 3 for Presence Capability | 703d | 2002-04-01 A | 2004-12-08 A | 100% | 2002-04-01 | 2004-12-08 | 703d | finish no earlier than 2004-12-08 | N1; N4 | 11248h | 11248h |  | Lucent | Keith Drage (drage@alcatel-lucent.com) | Rel-6 | Frederic |  |
| 7631 | 2404.4 | Stage 3 (CN3 Part Pk interface) | 770d? | 2002-04-01 A | 2005-03-11 A | 100% | 2002-04-01 | 2005-03-11 | 770d? | finish no earlier than 2005-03-11 | N3 | 6160h | 6160h |  | Lucent | Keith Drage (drage@alcatel-lucent.com) | Rel-6 | Gwiho |  |
| 7632 | 2404.5 | Media Codecs and Formats for IMS Messaging and Presence | 650d? | 2003-06-12 A | 2005-12-07 A | 100% | 2003-06-12 | 2005-12-07 | 650d? | finish no earlier than 2005-12-07 | S4 | 5200h | 5200h | PRESNC-COFIMP | Nokia | harri.honko@nokia.com | Rel-6 | Paolo | PRESNC-COFIMP |
| 7633 | 22.4 | Security aspects of Presence Capability | 79d | 2002-08-26 A | 2002-12-12 A | 100% | 2002-08-26 | 2002-12-12 | 79d | finish no earlier than 2002-12-12 | S3 | 632h | 632h |  | Ericsson | krister.boman@erv.ericsson.se | Rel-6 | Mirko |  |
| 7634 | 2404.7 | SIMPLE Presence | 326d? | 2004-01-01 A | 2005-03-31 A | 100% | 2004-01-01 | 2005-03-31 | 326d? | finish no earlier than 2004-12-30 | OMA | 2608h | 2608h |  |  | OMA-LIAISON@mail.openmobilealliance.org | Rel-6 |  |  |
| 7635 | 25 | **Enhanced A/Gb feasibility study** | 51d? | 2002-08-30 A | 2002-11-08 A | 100% | 2002-08-30 | 2002-11-08 | 51d? |  | GP | 3264h | 3264h | AGbEnFS | Vodafone | jose-luis.carrizo@vodafone.co.uk | Rel-6 | Paolo | AGbEnFS |
| 7636 | 25.1 | **Feasibility study on A/Gb enhancements** | 51d? | 2002-08-30 A | 2002-11-08 A | 100% | 2002-08-30 | 2002-11-08 | 51d? |  | G2 | 2856h | 2856h | AGbEnFS-FS | Vodafone | jose-luis.carrizo@vodafone.co.uk | Rel-6 | Gert | AGbEnFS-FS |
| 7637 | 25.1.1 | Requirements for the support of conversational services | 51d | 2002-08-30 A | 2002-11-08 A | 100% | 2002-08-30 | 2002-11-08 | 51d | finish no earlier than 2002-11-08 | GP | 408h | 408h |  |  |  | Rel-6 | Paolo |  |
| 7638 | 2405.1.2 | Identification of the different building blocks for the provision of conversational services on the existing A/Gb protocol stack | 51d? | 2002-08-30 A | 2002-11-08 A | 100% | 2002-08-30 | 2002-11-08 | 51d? | finish no earlier than 2002-11-08 | GP | 408h | 408h |  |  |  | Rel-6 | Paolo |  |
| 7639 | 2405.1.3 | Outline of impact and feasibility of these building blocks and their different solutions | 51d? | 2002-08-30 A | 2002-11-08 A | 100% | 2002-08-30 | 2002-11-08 | 51d? | finish no earlier than 2002-11-08 | GP | 408h | 408h |  |  |  | Rel-6 | Paolo |  |
| 7640 | 25.1.4 | Impact on 3GPP architecture and requirement to co-ordinatge with other TSGs (CN, SA) | 51d | 2002-08-30 A | 2002-11-08 A | 100% | 2002-08-30 | 2002-11-08 | 51d | finish no earlier than 2002-11-08 | GP | 408h | 408h |  |  |  | Rel-6 | Paolo |  |
| 7641 | 25.1.5 | Standardisation effort | 51d | 2002-08-30 A | 2002-11-08 A | 100% | 2002-08-30 | 2002-11-08 | 51d | finish no earlier than 2002-11-08 | GP | 408h | 408h |  |  |  | Rel-6 | Paolo |  |
| 7642 | 25.1.6 | Dependency to other features of Enhanced A/Gb feasibility study | 51d | 2002-08-30 A | 2002-11-08 A | 100% | 2002-08-30 | 2002-11-08 | 51d | finish no earlier than 2002-11-08 | GP | 408h | 408h |  |  |  | Rel-6 | Paolo |  |
| 7643 | 26 | **Flexible Layer One for GERAN** | 1171d | 2000-01-03 A | 2004-06-25 A | 100% | 2000-01-03 | 2004-06-25 | 1171d |  | GP; S3 | 86648h | 86648h | FLOGER | Nokia | benoist.sebire@nokia.com | Rel-6 | Paolo | FLOGER |
| 7644 | 26.1 | **Realisation of a Flexible Layer One** | 1126d | 2000-01-03 A | 2004-04-23 A | 100% | 2000-01-03 | 2004-04-23 | 1126d |  | GP | 42816h | 42816h | FLOGER-Real | Nokia | benoist.sebire@nokia.com | Rel-6 | Paolo | FLOGER-Real |
| 7645 | 26.1.1 | Technical Report on Realisation of a Flexible Layer One | 471d | 2002-04-19 A | 2004-02-06 A | 100% | 2002-04-19 | 2004-02-06 | 471d | finish no earlier than 2004-02-06 | GP | 3768h | 3768h |  | Nokia | benoist.sebire@nokia.com | Rel-6 | Paolo |  |
| 7646 | 26.1.2 | Architecture in 45.001 and 43.051 | 526d | 2002-04-19 A | 2004-04-23 A | 100% | 2002-04-19 | 2004-04-23 | 526d | finish no earlier than 2004-04-23 | G1 | 4208h | 4208h |  | Nokia | benoist.sebire@nokia.com | Rel-6 | Paolo |  |
| 7647 | 26.1.3 | Multiplexing in 45.002 | 526d | 2002-04-19 A | 2004-04-23 A | 100% | 2002-04-19 | 2004-04-23 | 526d | finish no earlier than 2004-04-23 | G1 | 4208h | 4208h |  | Nokia | benoist.sebire@nokia.com | Rel-6 | Paolo |  |
| 7648 | 26.1.4 | Channel Coding in 45.003 for Realisation of a Flexible Layer One | 526d | 2002-04-19 A | 2004-04-23 A | 100% | 2002-04-19 | 2004-04-23 | 526d | finish no earlier than 2004-04-23 | G1 | 4208h | 4208h |  | Nokia | benoist.sebire@nokia.com | Rel-6 | Paolo |  |
| 7649 | 26.1.5 | Performance Requirements in 45.005 for Realisation of a Flexible Layer One | 1126d | 2000-01-03 A | 2004-04-23 A | 100% | 2000-01-03 | 2004-04-23 | 1126d | finish no earlier than 2004-04-23 | G1 | 9000h | 9000h |  | Nokia | benoist.sebire@nokia.com | Rel-6 | Paolo |  |
| 7650 | 26.1.6 | Radio subsystem link control in 45.008 for Realisation of a Flexible Layer One | 526d | 2002-04-19 A | 2004-04-23 A | 100% | 2002-04-19 | 2004-04-23 | 526d | finish no earlier than 2004-04-23 | G1 | 4208h | 4208h |  | Nokia | benoist.sebire@nokia.com | Rel-6 | Paolo |  |
| 7651 | 26.1.7 | Requirements in 44.004 | 526d | 2002-04-19 A | 2004-04-23 A | 100% | 2002-04-19 | 2004-04-23 | 526d | finish no earlier than 2004-04-23 | G2 | 4208h | 4208h |  | Nokia | benoist.sebire@nokia.com | Rel-6 | Gert |  |

Notes:
- 7627: merged "Presence Service Enhancements" (UID31028, PRES1) to this feature as no answer was provided on why Presence and Presence Encmts had same target completion date
- 7628: TP#16 moved Stage 1 to Rel-6 TS 22.141 (existed already in Rel-5) / Impacted TSs and TRs: 22.141
- 7629: - / Impacted TSs and TRs: 23.002; 24.229; New 23.141
- 7630: Dependency to 2 IETF drafts, no known work at the moment / Impacted TSs and TRs: New N1 (24.141; 24.841); N4 (29.002; 29.228; 29.230; 29.328)
- 7631: - / Impacted TSs and TRs: 29.061; 29.161
- 7632: - / Impacted TSs and TRs: 26.141; 26.936
- 7633: SP#17 approved WID S3-020429
- 7634: SP#24 OMA LS_in update in SP-040232 OMA dependencies on 3GPP deliverables
- 7635: - / Impacted TSs and TRs: None
- 7636: - / Impacted TSs and TRs: None
- 7637: - / Impacted TSs and TRs: None
- 7638: - / Impacted TSs and TRs: None
- 7639: - / Impacted TSs and TRs: None
- 7640: - / Impacted TSs and TRs: None
- 7641: - / Impacted TSs and TRs: None
- 7642: - / Impacted TSs and TRs: None
- 7643: -
- 7644: -
- 7645: -
- 7646: -
- 7647: -
- 7648: -
- 7649: -
- 7650: -
- 7651: -

| ID | WBS | Task | Type | Duration | Start | Finish | Complete | Baseline start | Baseline finish | Baseline duration | Constraint | Resources | Work | Actual work | Acronym | WI rapporteur name | WI rapporteur e-mail | Release | MCC resp | Acronym_3GU_Export | Impacted TSs and TRs | TSG stopped |
| --- | --- | --- | --- | --- | --- | --- | --- | --- | --- | --- | --- | --- | --- | --- | --- | --- | --- | --- | --- | --- | --- | --- |
| 7652 | 26.2 | **Signalling and protocol support for a Flexible Layer One** |  | 571d | 2002-04-19 A | 2004-06-25 A | 100% | 2002-04-19 | 2004-06-25 | 571d |  | G2 | 13704h | 13704h | FLOGER-SigPro | Nokia | benoist.sebire@nokia.com | Rel-6 | Gert | FLOGER-SigPro |  |  |
| 7653 | 26.2.1 | Modifications to RLC/MAC in 44.060 and 44.160 |  | 571d | 2002-04-19 A | 2004-06-25 A | 100% | 2002-04-19 | 2004-06-25 | 571d | finish no earlier than 2004-06-25 | G2 | 4568h | 4568h |  | Nokia | benoist.sebire@nokia.com | Rel-6 | Gert |  |  |  |
| 7654 | 26.2.2 | Modifications to RRC in 44.118 and 44.018 |  | 571d | 2002-04-19 A | 2004-06-25 A | 100% | 2002-04-19 | 2004-06-25 | 571d | finish no earlier than 2004-06-25 | G2 | 4568h | 4568h |  | Nokia | benoist.sebire@nokia.com | Rel-6 | Gert |  |  |  |
| 7655 | 26.3 | **Security for a Flexible Layer One** |  | 356d | 2002-04-19 A | 2003-08-29 A | 100% | 2002-04-19 | 2003-08-29 | 356d |  | S3; G2 | 11392h | 11392h | FLOGER-SecFLO | Nokia | benoist.sebire@nokia.com | Rel-6 | Mirko | FLOGER-SecFLO |  |  |
| 7656 | 26.3.1 | Ciphering in 44.060, 44.160, 44.018, 44.118 |  | 356d | 2002-04-19 A | 2003-08-29 A | 100% | 2002-04-19 | 2003-08-29 | 356d | finish no earlier than 2003-08-29 | S3; G2 | 5696h | 5696h |  | Nokia | benoist.sebire@nokia.com | Rel-6 | Mirko |  | 44.060; 44.160; 44.018; 44.118 |  |
| 7657 | 26.4 | **Deleted - GERAN MS Conformance test for the Flexible Layer One - DELETE** |  | 0d | 2004-02-06 A | 2004-02-06 A | 100% | 2004-02-06 | 2004-02-06 | 0d |  | G4; G5 |  |  | FLOGER-Msconf | Nokia | benoist.sebire@nokia.com | Rel-6 | Paolo | FLOGER-Msconf |  | GP-27 |
| 7658 | 26.4.1 | Deleted at TSG #27 - MS Test in 51.010 | milestone | 0d | 2004-02-06 A | 2004-02-06 A | 100% | 2004-02-06 | 2004-02-06 | 0d | finish no earlier than 2004-02-06 | G4; G5 |  |  |  | Nokia | benoist.sebire@nokia.com | Rel-6 | Paolo |  |  | GP-22 |
| 7659 | 26.5 | **Deleted - GERAN BTS Conformance test for the Flexible Layer One - DELETE** |  | 0d | 2004-02-06 A | 2004-02-06 A | 100% | 2004-02-06 | 2004-02-06 | 0d |  | G3new |  |  | FLOGER-BTSconf | Nokia | benoist.sebire@nokia.com | Rel-6 | Ingbert | FLOGER-BTSconf |  | GP-27 |
| 7660 | 26.5.1 | Deleted at TGS #27 - BTS Test in 51.021 - DELETE | milestone | 0d | 2004-02-06 A | 2004-02-06 A | 100% | 2004-02-06 | 2004-02-06 | 0d | finish no earlier than 2004-02-06 | G3new |  |  |  | Nokia | benoist.sebire@nokia.com | Rel-6 | Ingbert |  |  | GP-22 |
| 7661 | 27 | Uplink TDOA feasibility study |  | 151d | 2001-11-30 A | 2002-06-28 A | 100% | 2001-11-30 | 2002-06-28 | 151d | finish no earlier than 2002-06-28 | GP | 1208h | 1208h | TDOAF | TruePosition | Bob Gross (rlgross@trueposition.com) | Rel-6 | Paolo | TDOAF | 45.811 |  |
| 7662 | 28 | **Multimedia Broadcast and Multicast Service** |  | 1781d? | 2001-05-11 A | 2008-03-07 A | 100% | 2001-05-11 | 2008-03-07 | 1781d? |  | S1; S2; S3; S4; S5; N1; N3; R2; R4; R5; T1; GP; G2; G3new | 391176h | 391176h | MBMS |  |  | Rel-6 | Alain | MBMS |  |  |
| 7663 | 28.1 | Stage 1 for Multimedia Broadcast and Multicast Service |  | 232d | 2001-05-11 A | 2002-04-01 A | 100% | 2001-05-11 | 2002-04-01 | 232d | finish no earlier than 2002-04-01 | S1 | 1856h | 1856h |  |  |  | Rel-6 | Alain |  | 22.146; 22.101 |  |
| 7664 | 28.2 | **Stage 2 for Multimedia Broadcast and Multicast Service** |  | 648d | 2001-09-24 A | 2004-03-17 A | 100% | 2001-09-24 | 2004-03-17 | 648d |  | S2 | 10408h | 10408h |  |  |  | Rel-6 | Maurice |  |  |  |
| 7665 | 28.2.1 | TR on MBMS Architectural Study |  | 240d | 2001-09-24 A | 2002-08-23 A | 100% | 2001-09-24 | 2002-08-23 | 240d | finish no earlier than 2002-08-23 | S2 | 1920h | 1920h |  |  |  | Rel-6 | Maurice |  | 23.846 |  |
| 7666 | 28.2.2 | Stage 2 MBMS Specification Work |  | 413d | 2002-08-19 A | 2004-03-17 A | 100% | 2002-08-19 | 2004-03-17 | 413d | finish no earlier than 2004-03-17 | S2 | 3304h | 3304h |  |  |  | Rel-6 | Maurice |  | 23.246 |  |
| 7667 | 28.4 | Support of the MBMS in CN protocols |  | 647d | 2002-06-18 A | 2004-12-08 A | 100% | 2002-06-18 | 2004-12-08 | 647d | finish no earlier than 2004-12-08 | N1 | 5176h | 5176h |  |  |  | Rel-6 | Frederic |  |  |  |
| 7668 | 2408.4 | Gmb interface for MBMS (CN3 part) |  | 334d | 2003-08-29 A | 2004-12-08 A | 100% | 2003-08-29 | 2004-12-08 | 334d | finish no earlier than 2004-12-08 | N3 | 2672h | 2672h |  |  |  | Rel-6 | Gwiho |  | 29.061 |  |
| 7669 | 28.5 | Security aspects of MBMS |  | 710d | 2002-07-01 A | 2005-03-18 A | 100% | 2002-07-01 | 2005-03-18 | 710d | finish no earlier than 2005-03-18 | S3 | 5680h | 5680h |  |  | adrian.escott@three.co.uk | Rel-6 | Mirko |  | New 33.246 |  |
| 7670 | 2408.6 | MBMS Charging |  | 108d? | 2005-01-11 A | 2005-06-09 A | 100% | 2005-01-11 | 2005-06-09 | 108d? | start no earlier than 2005-01-11 | S5 | 864h | 864h | MBMS-CH |  |  | Rel-6 | Mirko | MBMS-CH | 32.273 |  |
| 7671 | 28.1 | **MBMS User Services** |  | 743d? | 2003-05-13 A | 2006-03-16 A | 100% | 2003-05-13 | 2006-03-16 | 743d? |  | S1; S4 | 19520h | 19520h |  |  |  | Rel-6 | Alain |  |  |  |
| 7672 | 28.1 | Stage 1 for MBMS User Services |  | 233d | 2003-05-13 A | 2004-04-01 A | 100% | 2003-05-13 | 2004-04-01 | 233d | start no earlier than 2003-05-13 | S1 | 1864h | 1864h |  |  |  | Rel-6 | Alain |  | 22.246 |  |
| 7673 | 2408.7.2 | Definition of MBMS user services, media codecs, formats and transport/application protocols using MBMS |  | 721d? | 2003-06-12 A | 2006-03-16 A | 100% | 2003-06-12 | 2006-03-16 | 721d? | finish no earlier than 2006-03-16 | S4 | 5768h | 5768h | MBMS-TSMBMS | Nokia | igor.curcio@nokia.com | Rel-6 | Paolo | MBMS-TSMBMS | 26.346; 26.936; 26.946 |  |
| 7674 | 28.3 | **Introduction of MBMS in RAN** |  | 967d? | 2002-01-01 A | 2005-09-14 A | 100% | 2002-01-01 | 2005-09-14 | 967d? |  | R2; R4 | 23728h | 23728h | MBMS-RAN | Nokia | juho.pirskanen@nokia.com | Rel-6 | Yong-Jun | MBMS-RAN |  |  |
| 7675 | 2408.8.1 | Introduction of MBMS in RAN (physical & upper layers, access network interfaces) |  | 771d? | 2002-01-01 A | 2004-12-14 A | 100% | 2002-01-01 | 2004-12-14 | 771d? | finish no earlier than 2004-12-14 | R2 | 6168h | 6168h |  | Nokia | juho.pirskanen@nokia.com | Rel-6 | Yong-Jun |  | 25.346; 25.304; 25.321; 25.322; 25.323 |  |
| 7676 | 2408.8.2 | UE Performance Requirements for MBMS |  | 261d? | 2004-09-15 A | 2005-09-14 A | 100% | 2004-09-15 | 2005-09-14 | 261d? | finish no earlier than 2005-09-15 | R4 | 2088h | 2088h | MBMS-RAN-RF | Ericsson | Torgny.Palenius@ericsson.com | Rel-6 | Issam | MBMS-RAN-RF | 25.101; 25.133 |  |

Notes:
- 7652: -
- 7653: -
- 7654: -
- 7655: -
- 7656: -
- 7657: -
- 7658: -
- 7659: -
- 7660: -
- 7661: -
- 7662: SP#13 Title renamed
- 7663: -
- 7664: -
- 7665: -
- 7666: -
- 7667: -
- 7668: -
- 7669: SP#17 approved WID S3-020433
- 7670: SP#28 completed
- 7671: -
- 7672: -
- 7673: -
- 7674: -
- 7675: -
- 7676: RP#25 approved WID RP-040370

| ID | WBS | Task | Type | Duration | Start | Finish | Complete | Baseline start | Baseline finish | Baseline duration | Constraint | Deadline | Resources | Work | Actual work | Acronym | Release | MCC resp | Acronym_3GU_Export | Impacted TSs and TRs | WI rapporteur name | WI rapporteur e-mail | Created at | TSG stopped |
| --- | --- | --- | --- | --- | --- | --- | --- | --- | --- | --- | --- | --- | --- | --- | --- | --- | --- | --- | --- | --- | --- | --- | --- | --- |
| 7677 | 2408.9 | **MBMS UE Conformance Testing** |  | 521d? | 2006-03-10 A | 2008-03-07 A | 100% | 2006-03-10 | 2008-03-07 | 521d? |  |  | R5; T1 | 34400h | 34400h | MBMS-UEConTest | Rel-6 | Ingbert | MBMS-UEConTest |  |  |  |  |  |
| 7678 | 16.5.1 | RF/RRM Conformance Test Aspects – MBMS (FDD) |  | 461d | 2006-06-02 A | 2008-03-07 A | 100% | 2006-06-02 | 2008-03-07 | 461d | finish no earlier than 2008-03-07 | 2006-06-02 | R5; T1 | 7376h | 7376h | MBMS-RAN-RF_Test | Rel-6 | Ingbert | MBMS-RAN-RF_Test | 34.108; 34.109; 34.121-1; 34.121-2 | Ericsson | leif.mattisson@ericsson.com | Fri 11/03/05 |  |
| 7679 | 2408.9.2 | Conformance Test Aspects - MBMS for 3.84 Mcps and 7.68 Mcps TDD |  | 318d? | 2006-09-20 A | 2007-12-07 A | 100% | 2006-09-20 | 2007-12-07 | 318d? | finish no earlier than 2007-12-07 |  | R5; T1 | 5088h | 5088h | MBMS-UEConTest_TDH | Rel-6 | Ingbert | MBMS-UEConTest_TDH | 34.108; 34.122; 34.123-1; 34.123-2; 34.123-3 | IPWireless | Timothy Speight (tspeight@ipwireless.com) |  |  |
| 7680 | 2408.9.3 | Signalling Conformance Test Aspects – MBMS for LCR TDD |  | 318d? | 2006-09-20 A | 2007-12-07 A | 100% | 2006-09-20 | 2007-12-07 | 318d? | finish no earlier than 2007-12-07 |  | R5; T1 | 5088h | 5088h | MBMS-UEConTest_SIGTDL | Rel-6 | Ingbert | MBMS-UEConTest_SIGTDL | 34.108; 34.123-1; 34.123-2; 34.123-3 | Datang | zhaojian@datangmobile.cn |  |  |
| 7681 | 2408.9.4 | Conformance Test Aspects – MBMS |  | 396d? | 2006-03-10 A | 2007-09-14 A | 100% | 2006-03-10 | 2007-09-14 | 396d? | finish no earlier than 2007-09-14 |  | R5; T1 | 6336h | 6336h | MBMS_Test | Rel-6 | Ingbert | MBMS_Test | 34.108; 34.123-1; 34.123-2; 34.123-3 | Qualcomm | Shubhang Vora (svora@qualcomm.com) |  |  |
| 7682 | 16.5.1 | Conformance Test Aspects - 1.28 Mcps TDD MBMS RF/RRM |  | 136d | 2007-06-01 A | 2007-12-07 A | 100% | 2007-06-01 | 2007-12-07 | 136d | finish no earlier than 2007-12-07 | 2006-06-02 | R5; T1 | 2176h | 2176h | MBMS-UEConTest_RFTDL | Rel-6 | Ingbert | MBMS-UEConTest_RFTDL | 34.108; 34.109; 34.122 | Datang | chenxiaozhong@datangmobile.cn | Fri 11/03/05 |  |
| 7683 | 28.6 | **Support of MBMS in GERAN** |  | 892d? | 2001-08-30 A | 2005-01-28 A | 100% | 2001-08-30 | 2005-01-28 | 892d? |  |  | GP; G2; G3new | 87400h | 87400h | MBMS-GERAN | Rel-6 | Paolo | MBMS-GERAN |  |  |  |  |  |
| 7684 | 28.6.1 | MBMS Impact on the logical and physical channels |  | 631d | 2002-08-30 A | 2005-01-28 A | 100% | 2002-08-30 | 2005-01-28 | 631d | finish no earlier than 2005-01-28 |  | GP | 5048h | 5048h |  | Rel-6 | Paolo |  |  |  |  |  |  |
| 7685 | 28.6.4 | MBMS Re-synchronisation at cell change |  | 631d | 2002-08-30 A | 2005-01-28 A | 100% | 2002-08-30 | 2005-01-28 | 631d | finish no earlier than 2005-01-28 |  | G2 | 5048h | 5048h |  | Rel-6 | Gert |  |  |  |  |  |  |
| 7686 | 2408.10.3 | Simultaneous support of MBMS services |  | 631d? | 2002-08-30 A | 2005-01-28 A | 100% | 2002-08-30 | 2005-01-28 | 631d? | finish no earlier than 2005-01-28 |  | GP | 5048h | 5048h |  | Rel-6 | Paolo |  |  |  |  |  |  |
| 7687 | 2408.10.4 | Simultaneous support of MBMS and non-MBMS services |  | 892d? | 2001-08-30 A | 2005-01-28 A | 100% | 2001-08-30 | 2005-01-28 | 892d? | finish no earlier than 2005-01-28 |  | GP | 7136h | 7136h |  | Rel-6 | Paolo |  |  |  |  |  |  |
| 7688 | 2408.10.5 | MBMS Resynchronization at cell change |  | 892d? | 2001-08-30 A | 2005-01-28 A | 100% | 2001-08-30 | 2005-01-28 | 892d? | finish no earlier than 2005-01-28 |  | GP | 7136h | 7136h |  | Rel-6 | Paolo |  |  |  |  |  |  |
| 7689 | 28.6.5 | MBMS Decision making process between point-to-point or point-to-multipoint configurations |  | 631d | 2002-08-30 A | 2005-01-28 A | 100% | 2002-08-30 | 2005-01-28 | 631d | finish no earlier than 2005-01-28 |  | GP | 5048h | 5048h |  | Rel-6 | Paolo |  |  |  |  |  |  |
| 7690 | 28.6.6 | MBMS channel allocations procedures to multiple MSs |  | 631d | 2002-08-30 A | 2005-01-28 A | 100% | 2002-08-30 | 2005-01-28 | 631d | finish no earlier than 2005-01-28 |  | GP | 5048h | 5048h |  | Rel-6 | Paolo |  |  |  |  |  |  |
| 7691 | 28.6.7 | MBMS Changes to the Gb interface |  | 631d | 2002-08-30 A | 2005-01-28 A | 100% | 2002-08-30 | 2005-01-28 | 631d | finish no earlier than 2005-01-28 |  | GP | 5048h | 5048h |  | Rel-6 | Paolo |  |  |  |  |  |  |
| 7692 | 28.6.8 | GERAN specific changes to the Iu-ps interface for MBMS |  | 631d | 2002-08-30 A | 2005-01-28 A | 100% | 2002-08-30 | 2005-01-28 | 631d | finish no earlier than 2005-01-28 |  | GP | 5048h | 5048h |  | Rel-6 | Paolo |  |  |  |  |  |  |
| 7693 | 28.6.9 | Interaction between MBMS and Iu-flex |  | 631d | 2002-08-30 A | 2005-01-28 A | 100% | 2002-08-30 | 2005-01-28 | 631d | finish no earlier than 2005-01-28 |  | GP | 5048h | 5048h |  | Rel-6 | Paolo |  |  |  |  |  |  |
| 7694 | 28.6.10 | MBMS Security aspects |  | 631d | 2002-08-30 A | 2005-01-28 A | 100% | 2002-08-30 | 2005-01-28 | 631d | finish no earlier than 2005-01-28 |  | GP | 5048h | 5048h |  | Rel-6 | Paolo |  |  |  |  |  |  |
| 7695 | 2408.10.12 | MBMS-GERAN - MS conformance tests |  | 786d? | 2002-01-25 A | 2005-01-28 A | 100% | 2002-01-25 | 2005-01-28 | 786d? | finish no earlier than 2005-01-28 |  | G3new | 6288h | 6288h |  | Rel-6 | Ingbert |  |  |  |  |  |  |
| 7696 | 2408.10.13 | Deleted - MS conformance tests - G5 | milestone | 0d? | 2003-06-27 A | 2003-06-27 A | 100% | 2003-06-27 | 2003-06-27 | 0d? | start no earlier than 2003-06-27 |  | G5 |  |  |  | Rel-6 | Paolo |  |  |  |  |  | GP-19 |
| 7697 | 29 | **Speech Recognition and Speech Enabled Services** |  | 1105d? | 2001-10-08 A | 2005-12-30 A | 100% | 2001-10-08 | 2005-12-30 | 1105d? |  |  | S1; S2; S4; OMA | 46696h | 46696h | SRSES | Rel-6 | Alain | SRSES |  |  |  |  |  |
| 7698 | 29.1 | Speech Enabled Services Based on Distributed Speech Recognition (DSR) |  | 115d | 2001-10-08 A | 2002-03-15 A | 100% | 2001-10-08 | 2002-03-15 | 115d | finish no earlier than 2002-03-15 |  | S1 | 920h | 920h | DSR | Rel-6 | Alain | DSR | 22.977; 22.941; 23.207; 22.243 | Qualcomm | Dwilliams@qualcomm.com |  |  |
| 7699 | 29.2 | TR on Architectural impacts |  | 212d | 2003-05-12 A | 2004-03-02 A | 100% | 2003-05-12 | 2004-03-02 | 212d | finish no earlier than 2004-03-02 |  | S2 | 1696h | 1696h |  | Rel-6 | Maurice |  | 23.877 |  |  |  |  |
| 7700 | 2409.3 | Codec Work to Support Speech Recognition Framework for Automated Voice Services |  | 568d? | 2002-10-15 A | 2004-12-16 A | 100% | 2002-10-15 | 2004-12-16 | 568d? | finish no earlier than 2004-12-16 |  | S4 | 4544h | 4544h | SRSES-Codec | Rel-6 | Paolo | SRSES-Codec | 26.235; 26.236; 26.243; 26.177; 26.943 | Motorola | David Pearce (bdp003@motorola.com) |  |  |
| 7701 | 2409.4 | Multimodal support |  | 522d? | 2004-01-01 A | 2005-12-30 A | 100% | 2004-01-01 | 2005-12-30 | 522d? | finish no earlier than 2005-06-30 |  | OMA | 4176h | 4176h |  | Rel-6 | Paolo |  |  |  | OMA-LIAISON@mail.openmobilealliance.org | SP-24 |  |
| 7702 | 2409.5 | Deleted - SES codec negotiation at Session Description Protocol (SDP) | milestone | 0d? | 2003-06-04 A | 2003-06-04 A | 100% | 2003-06-04 | 2003-06-04 | 0d? | start no earlier than 2003-06-04 |  | N1 |  |  |  | Rel-6 | Frederic |  |  |  |  |  | NP-23 |

Notes:
- 7677: -
- 7678: -
- 7679: -
- 7680: -
- 7681: -
- 7682: -
- 7683: -
- 7684: -
- 7685: -
- 7686: -
- 7687: -
- 7688: -
- 7689: -
- 7690: -
- 7691: -
- 7692: -
- 7693: -
- 7694: -
- 7695: -
- 7696: -
- 7697: -
- 7698: -
- 7699: -
- 7700: -
- 7701: -
- 7702: Abandoned NP-23

| ID | WBS | Task | Type | Duration | Start | Finish | Complete | Baseline start | Baseline finish | Baseline duration | Constraint | Resources | Work | Actual work | Acronym | Release | MCC resp | Acronym_3GU_Export | WI rapporteur name | WI rapporteur e-mail | Created at | TSG stopped | Special Focus Doc |
| --- | --- | --- | --- | --- | --- | --- | --- | --- | --- | --- | --- | --- | --- | --- | --- | --- | --- | --- | --- | --- | --- | --- | --- |
| 7703 | 30 | **Generic User Profile Rel-6** |  | 889d | 2001-10-08 A | 2005-03-03 A | 100% | 2001-10-08 | 2005-03-03 | 889d |  | S1; S3; N4 | 38519.8h | 38519.8h | GUP | Rel-6 | Alain | GUP |  |  |  |  |  |
| 7704 | 30.1 | Stage 1 - Requirements for Generic User Profile |  | 430d | 2001-10-08 A | 2003-05-30 A | 100% | 2001-10-08 | 2003-05-30 | 430d | finish no earlier than 2002-12-09 | S1 | 3440h | 3440h |  | Rel-6 | Alain |  | T-Mobile | kurt.bischinger@t-mobile.at |  |  |  |
| 7705 | 30.3 | Stage 2 - Architecture |  | 355d | 2002-01-28 A | 2003-06-06 A | 100% | 2002-01-28 | 2003-06-06 | 355d | finish no earlier than 2003-06-06 | S2 | 2840h | 2840h |  | Rel-6 | Maurice |  | Nokia | harri.o.koskinen@nokia.com |  |  |  |
| 7706 | 30.2 | Stage 2 - Data Description Method |  | 586d | 2002-12-05 A | 2005-03-03 A | 100% | 2002-12-05 | 2005-03-03 | 586d | finish no earlier than 2005-03-03 | N4 | 4688h | 4688h |  | Rel-6 | Kimmo |  | T-Mobile | kurt.bischinger@t-mobile.at |  |  |  |
| 7707 | 30.5 | Stage 3 - Network |  | 468.98d | 2003-05-19 A | 2005-03-03 A | 100% | 2003-05-19 | 2005-03-03 | 468.98d | finish no earlier than 2005-03-03 | N4 | 3751.84h | 3751.84h |  | Rel-6 | Kimmo |  |  |  |  |  |  |
| 7708 | 30.6 | Security aspects of GUP |  | 308d | 2002-07-16 A | 2003-09-18 A | 100% | 2002-07-16 | 2003-09-18 | 308d | finish no earlier than 2003-09-18 | S3 | 2464h | 2464h |  | Rel-6 | Mirko |  | Lucent | Bradley Owen (bvowen@lucent.com) |  |  |  |
| 7709 | 31 | **Digital Rights Management** |  | 690d? | 2001-10-08 A | 2004-05-28 A | 100% | 2001-10-08 | 2004-05-28 | 690d? |  | S1; OMA | 15672h | 15672h | DRM | Rel-6 | Alain | DRM |  |  |  |  |  |
| 7710 | 31.1 | Requirements for Digital Rights Management |  | 179d | 2001-10-08 A | 2002-06-13 A | 100% | 2001-10-08 | 2002-06-13 | 179d | finish no earlier than 2002-06-13 | S1 | 1432h | 1432h |  | Rel-6 | Alain |  | Openwave | nicholas.wood@openwave.com |  |  |  |
| 7711 | 2411.2 | Stage 2 for Digital Rights Management |  | 107d? | 2004-01-01 A | 2004-05-28 A | 100% | 2004-01-01 | 2004-05-28 | 107d? | finish no earlier than 2004-05-28 | OMA | 856h | 856h |  | Rel-6 |  |  |  | OMA-LIAISON@mail.openmobilealliance.org | SP-24 |  |  |
| 7712 | 2411.3 | Stage 3 for Digital Rights Management |  | 107d? | 2004-01-01 A | 2004-05-28 A | 100% | 2004-01-01 | 2004-05-28 | 107d? | finish no earlier than 2004-05-28 | OMA | 856h | 856h |  | Rel-6 |  |  |  | OMA-LIAISON@mail.openmobilealliance.org | SP-24 |  |  |
| 7713 | 31.3 | Security for Digital Rights Management |  | 186d | 2002-06-17 A | 2003-03-03 A | 100% | 2002-06-17 | 2003-03-03 | 186d | finish no earlier than 2003-03-03 | OMA | 1488h | 1488h |  | Rel-6 |  |  |  |  |  |  |  |
| 7714 | 2411.5 | Deleted - Monitoring of Stages 2 and 3 progress (actual work to be done by OMA) | milestone | 0d? | 2003-03-21 A | 2003-03-21 A | 100% | 2003-03-21 | 2003-03-21 | 0d? | start no earlier than 2002-08-19 | S1 |  |  |  | Rel-6 | Alain |  |  |  |  | SP-19 |  |
| 7715 | 32 | **WLAN-UMTS Interworking Rel-6** |  | 1495d? | 2000-01-03 A | 2005-09-22 A | 100% | 2000-01-03 | 2005-09-22 | 1495d? |  | S1; S2; S3; S5; N1; N3; N4; T3 | 129192h | 129192h | WLAN | Rel-6 | Alain | WLAN | Telenor | frederic.paint@telenor.com |  |  | WLAN |
| 7716 | 32.1 | Technical Report on WLAN-UMTS Interworking |  | 901d? | 2000-01-03 A | 2003-06-13 A | 100% | 2000-01-03 | 2003-06-13 | 901d? | finish no earlier than 2003-06-13 | S1 | 7200h | 7200h | WLAN-TR | Rel-6 | Alain | WLAN-TR | T-mobile | Mark.Younge@t-mobile.com |  |  | WLAN |
| 7717 | 2412.2 | Stage 1 for WLAN-UMTS Interworking Rel-6 |  | 375d? | 2003-01-06 A | 2004-06-11 A | 100% | 2003-01-06 | 2004-06-11 | 375d? |  | S1 | 920h | 920h | WLAN-TS | Rel-6 | Alain | WLAN-TS | Telenor | frederic.paint@telenor.com | SP-24 |  | WLAN |
| 7718 | 32.2 | Architecture Definition for scenarii 2 and 3 |  | 571d | 2002-03-25 A | 2004-05-31 A | 100% | 2002-03-25 | 2004-05-31 | 571d | finish no earlier than 2004-05-31 | S2 | 4568h | 4568h |  | Rel-6 | Maurice |  |  |  |  |  | WLAN |
| 7719 | 32.3 | Security aspects of WLAN-UMTS Interworking |  | 125d | 2002-09-30 A | 2003-03-21 A | 100% | 2002-09-30 | 2003-03-21 | 125d | finish no earlier than 2003-03-21 | S3 | 1000h | 1000h |  | Rel-6 | Mirko |  | Ericsson, BT | luis.lopez-soria@ece.ericsson.se, colin.blanchard@bt.com |  |  | WLAN |
| 7720 | 2412.5 | Stage 3 - CN4 aspects |  | 334d? | 2003-05-23 A | 2004-09-01 A | 100% | 2003-05-23 | 2004-09-01 | 334d? | finish no earlier than 2004-09-01 | N4 | 2672h | 2672h | WLAN-IW | Rel-6 | Kimmo | WLAN-IW | Nokia | raquel.rodriguez@nokia.com |  |  | WLAN |
| 7721 | 2412.6 | Stage 3 - CN3 aspects (Wi Interface for Scenario 3) |  | 355d? | 2003-05-23 A | 2004-09-30 A | 100% | 2003-05-23 | 2004-09-30 | 355d? | start no earlier than 2003-05-23 | N3 | 2840h | 2840h |  | Rel-6 | Gwiho |  |  |  | SP-24 |  | WLAN |
| 7722 | 2412.7 | Stage 3 for scenario 2 |  | 339d? | 2003-05-23 A | 2004-09-08 A | 100% | 2003-05-23 | 2004-09-08 | 339d? | finish no earlier than 2004-09-08 | N1 | 2712h | 2712h |  | Rel-6 | Frederic |  |  |  |  |  | WLAN |
| 7723 | 2412.8 | Stage 3 for scenario 3 |  | 404d? | 2003-05-23 A | 2004-12-08 A | 100% | 2003-05-23 | 2004-12-08 | 404d? | finish no earlier than 2004-12-08 | N1 | 3232h | 3232h |  | Rel-6 | Frederic |  |  |  | SP-24 |  | WLAN |
| 7724 | 2412.9 | WLAN charging |  | 655d? | 2003-03-21 A | 2005-09-22 A | 100% | 2003-03-21 | 2005-09-22 | 655d? | finish no earlier than 2005-09-22 | S5 | 5240h | 5240h | WLAN-CH | Rel-6 | Mirko | WLAN-CH | Nokia | Benni ALEXANDER |  |  | WLAN |
| 7725 | 2412.10 | USIM enhancements for WLAN Interworking |  | 391d? | 2003-09-05 A | 2005-03-04 A | 100% | 2003-09-05 | 2005-03-04 | 391d? | finish no earlier than 2005-03-04 | T3 | 3128h | 3128h |  | Rel-6 | Xavier |  | Axalto | Jabellan@axalto.com |  |  | WLAN |
| 7726 | 33 | **Priority Service** |  | 347d? | 2002-05-30 A | 2003-09-26 A | 100% | 2002-05-30 | 2003-09-26 | 347d? |  | S1 | 6464h | 6464h | PRIOR1 | Rel-6 | Alain | PRIOR1 | Telcordia | James Garrahan (jgarraha@telcordia.com) |  |  | Public Safety (I-A) |
| 7727 | 33.1 | Feasibility Study on Priority Service |  | 1d | 2002-06-14 A | 2002-06-14 A | 100% | 2002-06-14 | 2002-06-14 | 1d | finish no earlier than 2002-06-14 | S1 | 8h | 8h | PRIOR-FS | Rel-6 | Alain | PRIOR-FS | Telcordia | James Garrahan (jgarraha@telcordia.com) |  |  | Public Safety (I-A) |
| 7728 | 33.2 | Stage 1 - Requirements for Priority Service |  | 340d | 2002-05-30 A | 2003-09-17 A | 100% | 2002-05-30 | 2003-09-17 | 340d | finish no earlier than 2003-09-17 | S1 | 2720h | 2720h | PRIOR-SR | Rel-6 | Alain | PRIOR-SR | Telcordia | James Garrahan (jgarraha@telcordia.com) |  |  | Public Safety (I-A) |
| 7729 | 2413.3 | Priority service implementation guide |  | 131d? | 2003-03-28 A | 2003-09-26 A | 100% | 2003-03-28 | 2003-09-26 | 131d? | finish no earlier than 2003-09-26 | S1 | 1048h | 1048h |  | Rel-6 | Alain |  | Telcordia | James Garrahan (jgarraha@telcordia.com) |  |  | Public Safety (I-A) |

Notes:
- 7703: -
- 7704: - / Impacted TSs and TRs: 22.240; 22.228
- 7705: - / Impacted TSs and TRs: 23.240
- 7706: TR approved in CN#26 / Impacted TSs and TRs: 23.241
- 7707: - / Impacted TSs and TRs: 29.240
- 7708: SP#19 approved WID / Impacted TSs and TRs: 33.102; 33.203; 33.210
- 7709: Foreseen start and completion dates introduced by MCC (no indication at all on the WID)
- 7710: -
- 7711: -
- 7712: -
- 7713: SA3 acknowledge role in WI at SA3#20. Active contribution S3#24, S3#25. S3 WID approved SP#17
- 7714: Replaced by UID 60005 and 60006
- 7715: -
- 7716: - / Impacted TSs and TRs: 22.934
- 7717: - / Impacted TSs and TRs: 22.101; 22.105
- 7718: - / Impacted TSs and TRs: 23.234
- 7719: SP#17 approved WID S3-020451 / Impacted TSs and TRs: 21.133; 33.106; 33.107; 33.108; 33.200; 33.203; 33.210; New 33.234
- 7720: WID approved at CN#19 / Impacted TSs and TRs: 29.234; 29.061
- 7721: - / Impacted TSs and TRs: 29.161
- 7722: -
- 7723: -
- 7724: - / Impacted TSs and TRs: 32.252
- 7725: - / Impacted TSs and TRs: 31.102
- 7726: -
- 7727: - / Impacted TSs and TRs: 22.950
- 7728: -
- 7729: - / Impacted TSs and TRs: 22.952

| ID | WBS | Task | Type | Duration | Start | Finish | Complete | Baseline start | Baseline finish | Baseline duration | Constraint | Deadline | Resources | Work | Actual work | Acronym | WI rapporteur name | WI rapporteur e-mail | Release | MCC resp | Acronym_3GU_Export | Created at | TSG stopped |
| --- | --- | --- | --- | --- | --- | --- | --- | --- | --- | --- | --- | --- | --- | --- | --- | --- | --- | --- | --- | --- | --- | --- | --- |
| 7730 | 34 | **Network Sharing** |  | 820d? | 2003-01-20 A | 2006-03-10 A | 100% | 2003-01-20 | 2006-03-10 | 820d? |  |  | S1; S2; N1; R2; R5 | 44936h | 44936h | NTShar | T-Mobile | michele.zarri@t-mobile.co.uk | Rel-6 | Alain | NTShar |  |  |
| 7731 | 34.1 | Technical Report on Network Sharing |  | 240d? | 2003-01-20 A | 2003-12-19 A | 100% | 2003-01-20 | 2003-12-19 | 240d? |  |  | S1 | 1920h | 1920h | NTShar-TR | T-Mobile | michele.zarri@t-mobile.co.uk | Rel-6 | Alain | NTShar-TR |  |  |
| 7732 | 2414.2 | Stage 1 - CRs to implement Network Sharing |  | 240d? | 2003-01-20 A | 2003-12-19 A | 100% | 2003-01-20 | 2003-12-19 | 240d? | finish no earlier than 2003-12-19 |  | S1 | 1920h | 1920h | NTSharCR | T-Mobile | michele.zarri@t-mobile.co.uk | Rel-6 | Alain | NTSharCR |  |  |
| 7733 | 2414.3 | Stage 2 for Network Sharing |  | 372d? | 2003-02-27 A | 2004-07-30 A | 100% | 2003-02-27 | 2004-07-30 | 372d? | finish no earlier than 2004-07-30 |  | S2 | 2976h | 2976h |  | T-Mobile | michele.zarri@t-mobile.co.uk | Rel-6 | Maurice |  |  |  |
| 7734 | 2414.4 | Network sharing - stage 3 |  | 404d? | 2003-05-23 A | 2004-12-08 A | 100% | 2003-05-23 | 2004-12-08 | 404d? | finish no earlier than 2004-12-08 |  | N1 | 3232h | 3232h |  | T-Mobile | michele.zarri@t-mobile.co.uk | Rel-6 | Frederic |  |  |  |
| 7735 | 2414.5 | Enhancement of the support of network sharing in the UTRAN | milestone | 0d | 2003-09-19 A | 2003-09-19 A | 100% | 2003-09-19 | 2003-09-19 | 0d |  |  | R2 |  |  | NTShar-UTRANEnh | TeliaSonera | Anders.Dahlen@TeliaSonera.com | Rel-6 | Yong-Jun | NTShar-UTRANEnh |  |  |
| 7736 | 16.5.1 | Conformance Test Aspects – Network Sharing |  | 261d | 2005-03-11 A | 2006-03-10 A | 100% | 2005-03-11 | 2006-03-10 | 261d | finish no earlier than 2006-03-10 | 2006-03-10 | R5 | 2088h | 2088h | NTShar-UTRANEnh_Test | TeliaSonera | Niklas.Wiren@TeliaSonera.com | Rel-6 | Ingbert | NTShar-UTRANEnh_Test | Fri 11/03/05 |  |
| 7737 | 35 | **QoS Improvements** |  | 628d? | 2002-07-15 A | 2004-12-08 A | 100% | 2002-07-15 | 2004-12-08 | 628d? |  |  | S2; N3 | 18152h | 18152h | QoS1 | Nokia |  | Rel-6 | Maurice | QoS1 |  |  |
| 7738 | 35.1 | FS on Dynamic Policy control enhancements for end-to-end QoS |  | 465d | 2002-07-15 A | 2004-04-23 A | 100% | 2002-07-15 | 2004-04-23 | 465d | finish no earlier than 2004-04-23 |  | S2 | 3720h | 3720h |  | Nortel | Claire Mousset | Rel-6 | Maurice |  |  |  |
| 7739 | 2415.2 | Definition of the Gq interface |  | 214d? | 2003-07-01 A | 2004-04-23 A | 100% | 2003-07-01 | 2004-04-23 | 214d? | finish no earlier than 2004-04-23 |  | S2 | 1712h | 1712h |  |  | Janne Rinne | Rel-6 | Maurice |  |  |  |
| 7740 | 2415.3 | Gq interface specification for Dynamic Policy control enhancements – Stage 3 |  | 334d | 2003-08-29 A | 2004-12-08 A | 100% | 2003-08-29 | 2004-12-08 | 334d | finish no earlier than 2004-12-08 |  | N3 | 2672h | 2672h |  | Nokia | Anna.Sillanpaai@nokia.com | Rel-6 | Gwiho |  |  |  |
| 7741 | 36 | **Subscriber certificates** |  | 728d? | 2002-02-25 A | 2004-12-08 A | 100% | 2002-02-25 | 2004-12-08 | 728d? |  |  | S3; S2; N1; N4; T3; OMA | 44512h | 44512h | SEC1-SC | Nokia | valtteri.niemi@nokia.com | Rel-6 | Mirko | SEC1-SC |  |  |
| 7742 | 36.1 | Stage 1 of Subscriber certificates |  | 144d | 2002-02-25 A | 2002-09-12 A | 100% | 2002-02-25 | 2002-09-12 | 144d | finish no earlier than 2002-09-12 |  | S3 | 1152h | 1152h |  | Nokia | valtteri.niemi@nokia.com | Rel-6 | Mirko |  |  |  |
| 7743 | 36.2 | Architecture review |  | 24d | 2002-10-14 A | 2002-11-14 A | 100% | 2002-10-14 | 2002-11-14 | 24d | finish no earlier than 2002-11-14 |  | S2 | 192h | 192h |  | Nokia |  | Rel-6 | Maurice |  |  |  |
| 7744 | 2416.3 | Stage 3 for Subscriber certificates |  | 313d? | 2003-09-19 A | 2004-11-30 A | 100% | 2003-09-19 | 2004-11-30 | 313d? | finish no earlier than 2004-11-30 |  | N4; T3 | 5008h | 5008h |  | Nokia | Lauri Laitinen | Rel-6 | Kimmo |  |  |  |
| 7745 | 2416.4 | Stage 3 Ua & Ub interfaces |  | 288d? | 2003-11-03 A | 2004-12-08 A | 100% | 2003-11-03 | 2004-12-08 | 288d? | finish no earlier than 2004-12-08 |  | N1 | 2304h | 2304h |  | Nokia |  | Rel-6 | Frederic |  |  |  |
| 7746 | 2416.5 | OMA dependencies on Subscriber certificates |  | 114d? | 2004-01-01 A | 2004-06-08 A | 100% | 2004-01-01 | 2004-06-08 | 114d? | finish no earlier than 2004-06-08 |  | OMA | 912h | 912h |  | Nokia | OMA-LIAISON@mail.openmobilealliance.org | Rel-6 |  |  | SP-24 |  |
| 7747 | 2417 | **Rel-6 Open Service Access (OSA) enhancements** |  | 616d? | 2002-10-31 A | 2005-03-10 A | 100% | 2002-10-31 | 2005-03-10 | 616d? |  |  | N5 | 22576h | 22576h | OSA3 | Alcatel | Chelo.Abarca@alcatel.fr | Rel-6 | Kimmo | OSA3 |  |  |
| 7748 | 2417.1 | Scope of the Open Service Access Release 6 |  | 66d? | 2003-03-28 A | 2003-06-27 A | 100% | 2003-03-28 | 2003-06-27 | 66d? | finish no earlier than 2003-06-27 |  | S1 | 528h | 528h |  |  |  | Rel-6 | Alain |  |  |  |
| 7749 | 2417.2 | OSA Stage 2 |  | 150d? | 2004-08-13 A | 2005-03-10 A | 100% | 2004-08-13 | 2005-03-10 | 150d? | finish no earlier than 2005-03-10 |  | N5 | 1200h | 1200h |  |  |  | Rel-6 | Kimmo |  |  |  |
| 7750 | 2417.3 | Multi Media Messaging function |  | 487d? | 2002-10-31 A | 2004-09-10 A | 100% | 2002-10-31 | 2004-09-10 | 487d? | finish no earlier than 2004-09-10 |  | N5 | 3896h | 3896h |  |  |  | Rel-6 | Kimmo |  |  |  |
| 7751 | 2417.4 | Policy management extensions |  | 292d? | 2002-10-31 A | 2003-12-12 A | 100% | 2002-10-31 | 2003-12-12 | 292d? | finish no earlier than 2003-12-12 |  | N5 | 2336h | 2336h |  |  |  | Rel-6 | Kimmo |  |  |  |
| 7752 | 2417.5 | TS on Presence and Availability Management (from the PRESNC WI) |  | 367d? | 2002-10-31 A | 2004-03-26 A | 100% | 2002-10-31 | 2004-03-26 | 367d? | finish no earlier than 2004-03-26 |  | N5 | 2936h | 2936h |  |  |  | Rel-6 | Kimmo |  |  |  |
| 7753 | 2417.6 | OSA interfaces at different levels of abstractions (Parlay X, Web services) |  | 305d? | 2003-07-14 A | 2004-09-10 A | 100% | 2003-07-14 | 2004-09-10 | 305d? | finish no earlier than 2004-09-10 |  | N5 | 2440h | 2440h |  |  |  | Rel-6 | Kimmo |  |  |  |
| 7754 | 2417.7 | Introduction of migration support mechanism |  | 290d? | 2002-10-31 A | 2003-12-10 A | 100% | 2002-10-31 | 2003-12-10 | 290d? | finish no earlier than 2003-12-12 |  | N5 | 2320h | 2320h |  |  |  | Rel-6 | Kimmo |  |  |  |
| 7755 | 2417.8 | Framework Function for Federation |  | 225d? | 2003-02-03 A | 2003-12-12 A | 100% | 2003-02-03 | 2003-12-12 | 225d? | finish no earlier than 2003-12-12 |  | N5 | 1800h | 1800h |  |  |  | Rel-6 | Kimmo |  |  |  |
| 7756 | 2417.9 | OMA potential overlaps with 3GPP OSA Stage 3 (Web services) |  | 196d? | 2003-12-18 A | 2004-09-16 A | 100% | 2003-12-18 | 2004-09-16 | 196d? | start no earlier than 2003-12-18 |  | OMA | 1568h | 1568h |  |  |  | Rel-6 |  |  | SP-24 |  |
| 7757 | 2417.10 | Deleted - TR on Presence and Availability Management (from the PRESNC WI) | milestone | 0d? | 2004-09-17 A | 2004-09-17 A | 100% | 2004-09-17 | 2004-09-17 | 0d? | start no earlier than 2004-09-17 |  | N5 |  |  |  |  |  | Rel-6 | Kimmo |  |  | NP-24 |

Notes:
- 7730: -
- 7731: - / Impacted TSs and TRs: 22.951
- 7732: - / Impacted TSs and TRs: 22.011; 22.101; 22.115; 22.129
- 7733: - / Impacted TSs and TRs: 23.002; 23.060; 23.221; 23.236; new 23.251; 23.851
- 7734: - / Impacted TSs and TRs: 23.008; 23.122; 24.007; 24.008; 29.018
- 7735: - / Impacted TSs and TRs: 25.401; 25.413; 25.331; 25.304
- 7736: - / Impacted TSs and TRs: 34.108; 34.123-1; 34.123-2; 34.123-3
- 7737: - / Impacted TSs and TRs: 23.107; 23.207; 23.221
- 7738: - / Impacted TSs and TRs: 23.917 withdrawn (Contenall in 23.207)
- 7739: - / Impacted TSs and TRs: 23.207
- 7740: [DAB - 25.05.04] - Delayed to Sept - possibly Dec 2004 / Impacted TSs and TRs: 29.207; 29.208; 29.209
- 7741: SP#14 approved WID
- 7742: - / Impacted TSs and TRs: New (33.220; 33.221; 33.222; 33.246; 33.919)
- 7743: -
- 7744: Finished in CN4#26 / Impacted TSs and TRs: 23.003; 23.008; 29.109; 29.230; T3 31.102; 31.103; 31.111
- 7745: - / Impacted TSs and TRs: 24.109
- 7746: Updated according to SP-040420
- 7747: CN#25: Updated WID NP-040351 replaces NP-040144. / Impacted TSs and TRs: 22.127; 23.198; 29.198; 29.199; 29.998
- 7748: -
- 7749: Inherited by CN5 from SA2 at TSG#25 Sep 2004. SA2's 23.127 (OSA/VHE Stage 2) replaced from Rel-6 onwards by a new CN5 TS 23.198 (Stage 2 OSA-only). / Impacted TSs and TRs: 23.198 OSA Stage 2-ONLY replaces 23.127 (OSA/VHE) from Rel-6 onwards
- 7750: - / Impacted TSs and TRs: 29.198-15
- 7751: - / Impacted TSs and TRs: 29.198; 29.998
- 7752: N5#26: Split WI into TS & TR. / Impacted TSs and TRs: 29.198-14
- 7753: - / Impacted TSs and TRs: 29.199
- 7754: - / Impacted TSs and TRs: 29.198; 29.998
- 7755: - / Impacted TSs and TRs: 29.198; 29.998
- 7756: TSG#25 Approved CN5 29.199 Parlay X Web services. Ongoing 3GPP/OMA co-ordination to avoid OMA producing conflicting/OVERLAPING specs (NP-040283/SP-040493).
- 7757: N5#26:TR Completion 09/04¦consistent with CN1 delayed Rel-6 completion.

| ID | WBS | Task | Duration | Start | Finish | Complete | Baseline start | Baseline finish | Baseline duration | Constraint | Resources | Work | Actual work | Acronym | WI rapporteur name | WI rapporteur e-mail | Release | MCC resp | Acronym_3GU_Export | TSG stopped |
| --- | --- | --- | --- | --- | --- | --- | --- | --- | --- | --- | --- | --- | --- | --- | --- | --- | --- | --- | --- | --- |
| 7758 | 39 | **Addition of frequency bands to GSM (TAPS)** | 676d | 2002-06-28 A | 2005-01-28 A | 100% | 2002-06-28 | 2005-01-28 | 676d |  | GP | 16640h | 16640h | TAPS | Nokia | Torben Themsen | Rel-6 | Paolo | TAPS |  |
| 7759 | 39.1 | **Addition of frequency bands to GSM – Changes to core specs** | 26d | 2002-11-15 A | 2002-12-20 A | 100% | 2002-11-15 | 2002-12-20 | 26d |  | G1 | 416h | 416h | TAPS-Specs | Nokia | Torben Themsen | Rel-6 | Paolo | TAPS-Specs |  |
| 7760 | 39.1.1 | Changes to core specs | 26d | 2002-11-15 A | 2002-12-20 A | 100% | 2002-11-15 | 2002-12-20 | 26d | finish no earlier than 2002-12-20 | G1 | 208h | 208h |  | Nokia | Torben Themsen | Rel-6 | Paolo |  |  |
| 7761 | 39.2 | **Deleted - Addition of frequency bands to GSM – Changes for conformance tests** | 676d | 2002-06-28 A | 2005-01-28 A | 100% | 2002-06-28 | 2005-01-28 | 676d |  | G4 | 10816h | 10816h | TAPS-Conf | Nokia | Torben Themsen | Rel-6 | Paolo | TAPS-Conf | GP-23 |
| 7762 | 39.2.1 | Deleted - 51.010-1 Add testing | 676d | 2002-06-28 A | 2005-01-28 A | 100% | 2002-06-28 | 2005-01-28 | 676d | finish no earlier than 2005-01-28 | G4 | 5408h | 5408h |  | Nokia | Torben Themsen | Rel-6 | Paolo |  | GP-23 |
| 7763 | 40 | **Seamless support of streaming services in A/Gb mode** | 1426d? | 2000-01-03 A | 2005-06-17 A | 100% | 2000-01-03 | 2005-06-17 | 1426d? |  | GP; S3 | 70312h | 70312h | SSStrea | Vodafone | José Luis Carrizo Martínez | Rel-6 | Paolo | SSStrea |  |
| 7764 | 40.1 | **Identification of requirements for streaming** | 46d? | 2003-06-27 A | 2003-08-29 A | 100% | 2003-06-27 | 2003-08-29 | 46d? |  | G1 | 736h | 736h |  | Vodafone | José Luis Carrizo Martínez | Rel-6 | Paolo |  |  |
| 7765 | 2419.1.1 | Requirements for streaming | 46d? | 2003-06-27 A | 2003-08-29 A | 100% | 2003-06-27 | 2003-08-29 | 46d? | finish no earlier than 2003-08-29 | G1 | 368h | 368h |  | Vodafone | José Luis Carrizo Martínez | Rel-6 | Paolo |  |  |
| 7766 | 40.2 | **Performance study of cell change mechanisms** | 956d? | 2000-01-03 A | 2003-08-29 A | 100% | 2000-01-03 | 2003-08-29 | 956d? |  | G1 | 30568h | 30568h |  | Vodafone | José Luis Carrizo Martínez | Rel-6 | Paolo |  |  |
| 7767 | 2419.2.1 | Performance of NACC | 956d? | 2000-01-03 A | 2003-08-29 A | 100% | 2000-01-03 | 2003-08-29 | 956d? | finish no earlier than 2003-08-29 | G1 | 7640h | 7640h |  | Vodafone | José Luis Carrizo Martínez | Rel-6 | Paolo |  |  |
| 7768 | 2419.2.2 | Performance of cell change in DTM for the PS domain | 956d? | 2000-01-03 A | 2003-08-29 A | 100% | 2000-01-03 | 2003-08-29 | 956d? | finish no earlier than 2003-08-29 | G1 | 7640h | 7640h |  | Vodafone | José Luis Carrizo Martínez | Rel-6 | Paolo |  |  |
| 7769 | 2419.2.3 | Handover for Seamless support of streaming services in A/Gb mode | 956d? | 2000-01-03 A | 2003-08-29 A | 100% | 2000-01-03 | 2003-08-29 | 956d? | finish no earlier than 2003-08-29 | G1 | 7640h | 7640h |  | Vodafone | José Luis Carrizo Martínez | Rel-6 | Paolo |  |  |
| 7770 | 40.3 | **Reduction of service interruption times and packet loss during mobility procedures** | 516d? | 2003-06-27 A | 2005-06-17 A | 100% | 2003-06-27 | 2005-06-17 | 516d? |  | G2 | 10800h | 10800h |  | Vodafone | José Luis Carrizo Martínez | Rel-6 | Gert |  |  |
| 7771 | 2419.3.1 | optimizations of existing mechanisms/procedures | 106d? | 2003-06-27 A | 2003-11-21 A | 100% | 2003-06-27 | 2003-11-21 | 106d? | finish no earlier than 2003-11-21 | G2 | 848h | 848h |  | Vodafone | José Luis Carrizo Martínez | Rel-6 | Gert |  |  |
| 7772 | 2419.3.2 | Inter-system NACC | 106d? | 2003-06-27 A | 2003-11-21 A | 100% | 2003-06-27 | 2003-11-21 | 106d? | finish no earlier than 2003-11-21 | G2 | 848h | 848h |  | Vodafone | José Luis Carrizo Martínez | Rel-6 | Gert |  |  |
| 7773 | 2419.3.3 | PS Handover (within GERAN and between GERAN and UTRAN) | 516d? | 2003-06-27 A | 2005-06-17 A | 100% | 2003-06-27 | 2005-06-17 | 516d? | finish no earlier than 2003-11-21 | G2 | 4128h | 4128h |  | Vodafone | José Luis Carrizo Martínez | Rel-6 | Gert |  |  |
| 7774 | 2419.3.4 | Dependency to other features of Reduction of service interruption times and packet loss during mobility procedures | 106d? | 2003-06-27 A | 2003-11-21 A | 100% | 2003-06-27 | 2003-11-21 | 106d? | finish no earlier than 2003-11-21 | G2 | 848h | 848h |  | Vodafone | José Luis Carrizo Martínez | Rel-6 | Gert |  |  |
| 7775 | 40.5 | **Deleted - MS conformance testing for Seamless support of streaming services in A/Gb mode** | 31d? | 2003-12-19 A | 2004-01-30 A | 100% | 2003-12-19 | 2004-01-30 | 31d? |  | G3new | 496h | 496h |  | Vodafone | José Luis Carrizo Martínez | Rel-6 | Ingbert |  | GP-27 |
| 7776 | 2419.4.1 | Deleted - MS conformance tests for Seamless support of streaming services in A/Gb mode | 31d? | 2003-12-19 A | 2004-01-30 A | 100% | 2003-12-19 | 2004-01-30 | 31d? | finish no earlier than 2004-01-30 | G4; G5 | 496h | 496h |  | Vodafone | José Luis Carrizo Martínez | Rel-6 | Ingbert |  | GP-27 |
| 7777 | 2419.5 | GERAN A/Gb mode security enhancements | 612d? | 2002-09-26 A | 2005-01-28 A | 100% | 2002-09-26 | 2005-01-28 | 612d? | finish no earlier than 2005-01-28 | S3 | 4896h | 4896h |  | Vodafone | peter.howard@vodafone.com | Rel-6 | Mirko |  |  |
| 7778 | 41 | Performance characterisation of default codecs for PS conversational multimedia application | 455d | 2002-09-13 A | 2004-06-10 A | 100% | 2002-09-13 | 2004-06-10 | 455d | finish no earlier than 2004-06-10 | S4 | 3640h | 3640h | CODCAR | Nokia | pasi.s.ojala@nokia.com | Rel-6 | Paolo | CODCAR |  |
| 7779 | 43 | Study on Privacy Capability | 83d | 2003-11-10 A | 2004-03-03 A | 100% | 2003-11-10 | 2004-03-03 | 83d | start no earlier than 2003-11-10 | S1 | 664h | 664h | PrivCap | Lucent | Michael Boote (mboote@alcatel-lucent.com) | Rel-6 | Alain | PrivCap |  |
| 7780 | 44 | **Rel-6 Operations, Administration, Maintenance and Provisioning (OAM&P)** | 652d? | 2002-09-12 A | 2005-03-11 A | 100% | 2002-09-12 | 2005-03-11 | 652d? |  | S5 | 42635.5h | 42635.5h | OAM6 |  |  | Rel-6 | Mirko | OAM6 |  |
| 7781 | 44.1 | Principles, high level Requirements and Architecture | 526d | 2002-09-12 A | 2004-09-16 A | 100% | 2002-09-12 | 2004-09-16 | 526d | finish no earlier than 2004-09-16 | S5 | 4208h | 4208h |  | Motorola |  | Rel-6 | Mirko |  |  |
| 7782 | 44.2 | Performance Management | 591d | 2002-09-12 A | 2004-12-16 A | 100% | 2002-09-12 | 2004-12-16 | 591d | finish no earlier than 2004-12-16 | S5 | 4728h | 4728h |  | Nortel |  | Rel-6 | Mirko |  |  |
| 7783 | 44.4 | Network Infrastructure Management | 591d | 2002-09-12 A | 2004-12-16 A | 100% | 2002-09-12 | 2004-12-16 | 591d | finish no earlier than 2004-12-16 | S5 | 4728h | 4728h |  | Ericsson | thomas.tovinger@ericsson.com | Rel-6 | Mirko |  |  |

Notes:
- 7758: -
- 7759: -
- 7760: -
- 7761: -
- 7762: -
- 7763: -
- 7764: -
- 7765: -
- 7766: -
- 7767: -
- 7768: -
- 7769: -
- 7770: Completed at GERP#17
- 7771: -
- 7772: -
- 7773: -
- 7774: -
- 7775: Marked as stopped 10/2009
- 7776: Marked as stopped 10/2009
- 7777: SP#19 approved WID / Impacted TSs and TRs: 33.102
- 7778: - / Impacted TSs and TRs: 26.935
- 7779: - / Impacted TSs and TRs: 22.949
- 7780: SP#26: Updated WID SP-040766 was SP-020445. Completion delayed 12/04->03/05 due to OAM-Trace in CN1/4.
- 7781: SP#25 09/2004 completed / Impacted TSs and TRs: 32.101; 32.102
- 7782: SP#26 12/2004 completed / Impacted TSs and TRs: 32.401; 32.403; 52.402; 32.411; 32.412; 32.413; 32.432; 32.435; 32.436
- 7783: SP#26 12/2004 completed / Impacted TSs and TRs: 32.150/1/2; 32.805; 32.111-5; 32.313/4; 32.331/2/3/4/5; 32.341/2/3/4; 32.351/2/3/4; 32.361/2/3/4; 32.371/2/3/4; 32.804; 32.675; 32.690; 32.695; 32.71/2/3/4/5; 32.741/2/3/4/5

| ID | WBS | Task | Duration | Start | Finish | Complete | Baseline start | Baseline finish | Baseline duration | Constraint | Resources | Work | Actual work | Acronym | WI rapporteur name | WI rapporteur e-mail | Release | MCC resp | Acronym_3GU_Export | Impacted TSs and TRs | Created at | TSG stopped |
| --- | --- | --- | --- | --- | --- | --- | --- | --- | --- | --- | --- | --- | --- | --- | --- | --- | --- | --- | --- | --- | --- | --- |
| 7784 | 44.5 | **Rel-6 Trace Management** | 646d? | 2002-09-20 A | 2005-03-11 A | 100% | 2002-09-20 | 2005-03-11 | 646d? |  | S5; N4; R3 | 23877.9h | 23877.9h | OAM-Trace | Nokia | kari.t.ronka@nokia.com | Rel-6 | Mirko | OAM-Trace |  |  |  |
| 7785 | 2422.4.1 | Subscriber and UE trace management | 585d | 2002-09-20 A | 2004-12-16 A | 100% | 2002-09-20 | 2004-12-16 | 585d | finish no earlier than 2004-12-16 | S5 | 4680h | 4680h |  | Nokia | kari.t.ronka@nokia.com | Rel-6 | Mirko |  | 32.421; 32.422; 32.423; 52.008 |  |  |
| 7786 | 2422.4.2 | Subscriber and equipment trace in UTRAN | 268d? | 2003-06-06 A | 2004-06-15 A | 100% | 2003-06-06 | 2004-06-15 | 268d? | finish no earlier than 2004-06-15 | R3 | 2144h | 2144h | OAM-Trace-RAN | Nortel | Yann Sehedi (sehedic@nortelnetworks.com) | Rel-6 | Juha | OAM-Trace-RAN | 25.413; 25.420; 25.423 |  |  |
| 7787 | 2422.4.3 | Trace Management, Stage3 | 193.74d? | 2004-06-09 A | 2005-03-11 A | 100% | 2004-06-09 | 2005-03-11 | 193.74d? | finish no earlier than 2005-03-11 | N4 | 1549.92h | 1549.92h |  | Nokia | seppo.kauntola@nokia.com | Rel-6 | Kimmo |  | 23.205; 29.232; 29.060; 29.002; 29.228 |  |  |
| 7788 | 2423 | **Rel-6 Charging Management** | 666d? | 2002-11-21 A | 2005-06-09 A | 100% | 2002-11-21 | 2005-06-09 | 666d? |  | S5; S2; N3 | 67152h | 67152h | CH | T-Mobile | karl-heinz.nenner@t-mobile.de | Rel-6 | Mirko | CH |  |  |  |
| 7789 | 2423.1 | Charging architecture and principles | 390d? | 2003-03-21 A | 2004-09-16 A | 100% | 2003-03-21 | 2004-09-16 | 390d? | start no earlier than 2003-03-21 | S5 | 3120h | 3120h |  |  |  | Rel-6 | Mirko |  | 32.240 |  |  |
| 7790 | 2423.2 | Charging Data Record (CDR) file format and transfer | 260d? | 2003-03-21 A | 2004-03-18 A | 100% | 2003-03-21 | 2004-03-18 | 260d? | start no earlier than 2003-03-21 | S5 | 2080h | 2080h |  |  |  | Rel-6 | Mirko |  | 32.297 |  |  |
| 7791 | 2423.3 | CDR parameter description | 580d? | 2003-03-21 A | 2005-06-09 A | 100% | 2003-03-21 | 2005-06-09 | 580d? | finish no earlier than 2005-06-09 | S5 | 4640h | 4640h |  |  |  | Rel-6 | Mirko |  | 32.298 |  |  |
| 7792 | 2423.4 | Diameter charging applications | 390d? | 2003-03-21 A | 2004-09-16 A | 100% | 2003-03-21 | 2004-09-16 | 390d? | start no earlier than 2003-03-21 | S5 | 3120h | 3120h |  |  |  | Rel-6 | Mirko |  | 32.299 |  |  |
| 7793 | 2423.5 | Online Charging System (OCS) architecture study | 130d? | 2003-03-21 A | 2003-09-18 A | 100% | 2003-03-21 | 2003-09-18 | 130d? | start no earlier than 2003-03-21 | S5 | 1040h | 1040h |  |  |  | Rel-6 | Mirko |  | 32.815 |  |  |
| 7794 | 2423.6 | OCS: Applications and interfaces | 455d? | 2003-03-21 A | 2004-12-16 A | 100% | 2003-03-21 | 2004-12-16 | 455d? | start no earlier than 2003-03-21 | S5 | 3640h | 3640h |  |  |  | Rel-6 | Mirko |  | 32.296 |  |  |
| 7795 | 2423.7 | **Charging Management for Bearer level** | 390d? | 2003-03-21 A | 2004-09-16 A | 100% | 2003-03-21 | 2004-09-16 | 390d? |  | S5 | 11440h | 11440h | CH-BC | Nokia | Benni ALEXANDER | Rel-6 | Mirko | CH-BC |  |  |  |
| 7796 | 2423.7.1 | CS domain charging | 260d? | 2003-03-21 A | 2004-03-18 A | 100% | 2003-03-21 | 2004-03-18 | 260d? | start no earlier than 2003-03-21 | S5 | 2080h | 2080h |  |  |  | Rel-6 | Mirko |  | 32.250 |  |  |
| 7797 | 2423.7.2 | PS domain charging | 390d? | 2003-03-21 A | 2004-09-16 A | 100% | 2003-03-21 | 2004-09-16 | 390d? | start no earlier than 2003-03-21 | S5 | 3120h | 3120h |  |  |  | Rel-6 | Mirko |  | 32.251 |  |  |
| 7798 | 2423.7.3 | CDR transfer | 390d? | 2003-03-21 A | 2004-09-16 A | 100% | 2003-03-21 | 2004-09-16 | 390d? | start no earlier than 2003-03-21 | S5 | 3120h | 3120h |  |  |  | Rel-6 | Mirko |  | 32.295 |  |  |
| 7799 | 2423.8 | Charging Management for the Service domain | 580d? | 2003-03-21 A | 2005-06-09 A | 100% | 2003-03-21 | 2005-06-09 | 580d? | finish no earlier than 2005-06-09 | S5 | 4640h | 4640h |  | Siemens | Gerald.Goermer@nsn.com | Rel-6 | Mirko |  | 32.252; 32.270; 32.271; 32.272 |  |  |
| 7800 | 2423.9 | **Overall architectural aspects of IP flow based bearer level charging** | 602d? | 2002-11-21 A | 2005-03-11 A | 100% | 2002-11-21 | 2005-03-11 | 602d? |  | S2; N3 | 17448h | 17448h | CH-FBC |  |  | Rel-6 | Maurice | CH-FBC | 23.125 |  |  |
| 7801 | 2423.9.1 | Overall definition of FBC architecture | 334d? | 2002-11-21 A | 2004-03-02 A | 100% | 2002-11-21 | 2004-03-02 | 334d? | start no earlier than 2002-11-21 | S2 | 2672h | 2672h |  |  |  | Rel-6 | Maurice |  |  | SP-24 |  |
| 7802 | 2423.9.2 | Study on providing policy control with FBC | 130d? | 2004-02-02 A | 2004-07-30 A | 100% | 2004-02-02 | 2004-07-30 | 130d? | start no earlier than 2004-02-01 | S2 | 1040h | 1040h |  |  |  | Rel-6 | Maurice |  |  | SP-24 |  |
| 7803 | 2423.9.3 | Gx interface for flow based charging | 223d? | 2004-02-02 A | 2004-12-08 A | 100% | 2004-02-02 | 2004-12-08 | 223d? | start no earlier than 2004-02-01 | N3 | 1784h | 1784h |  | Nokia | juha.a.rasanen@nokia.com | Rel-6 | Gwiho |  | 29.210 | SP-25 |  |
| 7804 | 2423.9.4 | Rx interface for flow based charging | 290d? | 2004-02-02 A | 2005-03-11 A | 100% | 2004-02-02 | 2005-03-11 | 290d? | finish no earlier than 2005-03-11 | N3 | 2320h | 2320h |  | Nortel | Javier Gonzalez Gallego | Rel-6 | Gwiho |  | 29.209 | SP-25 |  |
| 7805 | 13 | **Rel-6 UICC/USIM enhancements and interworking** | 1164d? | 2000-09-25 A | 2005-03-10 A | 100% | 2000-09-25 | 2005-03-10 | 1164d? |  | T3 | 43088h | 43088h | USAT1 |  |  | Rel-6 | Xavier | USAT1 |  |  |  |
| 7806 | 13.1 | **UICC API** | 777d | 2002-03-20 A | 2005-03-10 A | 100% | 2002-03-20 | 2005-03-10 | 777d |  | T3 | 15024h | 15024h | USAT1-API |  |  | Rel-6 | Xavier | USAT1-API |  |  |  |
| 7807 | 13.1.1 | Rel-6 Java API Test specification | 59d | 2002-03-20 A | 2002-06-10 A | 100% | 2002-03-20 | 2002-06-10 | 59d | finish no earlier than 2002-09-20 | T3 | 472h | 472h |  | Microelectrónica Española | Mario Pérez | Rel-6 | Xavier |  |  |  |  |
| 7808 | 2424.1.2 | 2G/3G Java Card™ API based applet interworking | 255d | 2003-03-17 A | 2004-03-05 A | 100% | 2003-03-17 | 2004-03-05 | 255d | finish no earlier than 2004-02-19 | T3 | 2040h | 2040h |  | Oberthur Card Systems | Stéphane Andrau | Rel-6 | Xavier |  |  |  |  |
| 7809 | 2424.1.3 | (U)SIM API for Java Card Testing | 519d | 2003-03-17 A | 2005-03-10 A | 100% | 2003-03-17 | 2005-03-10 | 519d | finish no earlier than 2005-03-10 | T3 | 4152h | 4152h |  | Axalto | Christophe Begassat (cbegassat@axalto.com) | Rel-6 | Xavier |  | 31.213 |  |  |
| 7810 | 13.1.2 | Deleted - Java API Test specification (TS 43.019 Rel-5) | 268d | 2002-05-30 A | 2003-06-09 A | 100% | 2002-05-30 | 2003-06-09 | 268d | finish no earlier than 2003-09-17 | T3 | 2144h | 2144h |  | Microelectrónica Española | Mario Pérez | Rel-6 | Xavier |  |  |  | TP-20 |

Notes:
- 7784: SP#26 12/2004 SA5 completed 12/04. Signalling Based Trace Activation for IMS (SIP) moved to Rel-7. Reason: CN1 cannot complete 24.229 trace without IETF dependency => estimate 05/2005.
- 7785: SP#26 12/2004 completed
- 7786: -
- 7787: -
- 7788: SP#28 Target 09/2005 for WLAN Charging 32.252
- 7789: SP#25 09/2004 completed
- 7790: SP#23 03/2004 completed
- 7791: SP#28 06/2005 completed
- 7792: SP#25 09/2004 completed
- 7793: SP#21 09/2003 completed
- 7794: SP#26 12/2004 completed
- 7795: SP#28 Target 09/2005 for WLAN Charging 32.252
- 7796: SP#23 03/2004 completed
- 7797: SP#25 09/2004 completed
- 7798: SP#25 09/2004 completed
- 7799: SP#26: Updated WID SP-040778 was SP-030050. Target completion 06/2005. Consisting of MMS-CH, LCS-CH, WLAN-CH, POC-CH, MBMS-CH
- 7800: -
- 7801: -
- 7802: -
- 7803: -
- 7804: -
- 7805: -
- 7806: 8/3/2001: test spec is based on R99 core spec, so deleted from Workplan
- 7807: -
- 7808: -
- 7809: -
- 7810: MOVED to Rel-5 WP

| ID | WBS | Task | Type | Duration | Start | Finish | Complete | Remaining | Baseline start | Baseline finish | Baseline duration | Total slack | Constraint | Resources | Work | Actual work | Acronym | WI rapporteur name | WI rapporteur e-mail | Release | MCC resp | Acronym_3GU_Export | TSG stopped |
| --- | --- | --- | --- | --- | --- | --- | --- | --- | --- | --- | --- | --- | --- | --- | --- | --- | --- | --- | --- | --- | --- | --- | --- |
| 7811 | 2424.2 | **Rel-6 USIM toolkit enhancements** |  | 1160d? | 2000-09-25 A | 2005-03-04 A | 100% |  | 2000-09-25 | 2005-03-04 | 1160d? |  |  | T3 | 21848h | 21848h | USAT1-API-MULTOS | Aspects Software | Neil Livingston | Rel-6 | Xavier | USAT1-API-MULTOS |  |
| 7812 | 2424.2.1 | **C SIM API** |  | 525d | 2000-09-25 A | 2002-09-27 A | 100% |  | 2000-09-25 | 2002-09-27 | 525d |  |  | T3 | 9960h | 9960h |  | Aspects Software | Neil Livingston | Rel-6 | Xavier |  |  |
| 7813 | 2424.2.1.1 | Specification of C SIM API |  | 525d | 2000-09-25 A | 2002-09-27 A | 100% |  | 2000-09-25 | 2002-09-27 | 525d |  | finish no earlier than 2002-09-27 | T3 | 4200h | 4200h |  | Aspects Software | Neil Livingston | Rel-6 | Xavier |  |  |
| 7814 | 2424.2.1.2 | Test specification for C SIM API |  | 195d | 2001-01-01 A | 2001-09-28 A | 100% |  | 2001-01-01 | 2001-09-28 | 195d |  | finish no earlier than 2001-09-28 | T3 | 1560h | 1560h |  | Aspects Software | Neil Livingston | Rel-6 | Xavier |  |  |
| 7815 | 2424.2.2 | USIM application toolkit Conformance Test Specification for Mobile Equipments |  | 326d? | 2003-12-05 A | 2005-03-04 A | 100% |  | 2003-12-05 | 2005-03-04 | 326d? |  | start no earlier than 2003-12-05 | T3 | 2608h | 2608h |  | Gemplus | Eric.laffont@gemplus.com | Rel-6 | Xavier |  |  |
| 7816 | 2425 | **Packet Switched Streaming Services Rel-6** |  | 798d? | 2002-11-18 A | 2005-12-07 A | 100% |  | 2002-11-18 | 2005-12-07 | 798d? |  |  | S4; S1 | 19688h | 19688h | PSSrel6 | Ericsson | olle.franceschi@ericsson.com | Rel-6 | Paolo | PSSrel6 |  |
| 7817 | 2425.1 | Stage 1 for Packet Switched Streaming Services Rel-6 |  | 86d? | 2002-11-18 A | 2003-03-17 A | 100% |  | 2002-11-18 | 2003-03-17 | 86d? |  | finish no earlier than 2003-03-17 | S1 | 688h | 688h |  | Ericsson |  | Rel-6 | Alain |  |  |
| 7818 | 2425.2 | Stage 3 for Packet Switched Streaming Services Rel-6 |  | 779d? | 2002-12-13 A | 2005-12-07 A | 100% |  | 2002-12-13 | 2005-12-07 | 779d? |  | finish no earlier than 2005-12-07 | S4 | 6232h | 6232h | PSSrel6-Stage3 | Ericsson | olle.franceschi@ericsson.com | Rel-6 | Paolo | PSSrel6-Stage3 |  |
| 7819 | 2426 | AMR-WB extension for high audio quality |  | 779d | 2002-12-13 A | 2005-12-07 A | 100% |  | 2002-12-13 | 2005-12-07 | 779d |  | finish no earlier than 2005-12-07 | S4 | 6232h | 6232h | AMRWB+ | Nokia | janne.m.vainio@nokia.com | Rel-6 | Paolo | AMRWB+ |  |
| 7820 | 2427 | Codec Enhancements for Packet Switched Conversational Multimedia Applications |  | 198d? | 2004-03-16 A | 2004-12-16 A | 100% |  | 2004-03-16 | 2004-12-16 | 198d? |  | finish no earlier than 2004-12-16 | S4 | 1584h | 1584h | CEPSCM | Nokia | miska.hannuksela@nokia.com | Rel-6 | Paolo | CEPSCM |  |
| 7821 | 2428 | 3G-324M Improvements |  | 198d? | 2004-03-16 A | 2004-12-16 A | 100% |  | 2004-03-16 | 2004-12-16 | 198d? |  | finish no earlier than 2004-12-16 | S4 | 1584h | 1584h | 3G-324MI | Ericsson | bo.burman@ericsson.com | Rel-6 | Paolo | 3G-324MI |  |
| 7822 | 2429 | Single Antenna Receiver Interference Cancellation (SAIC) |  | 420.92d? | 2002-11-15 A | 2004-06-25 A | 100% |  | 2002-11-15 | 2004-06-25 | 420.92d? |  | finish no earlier than 2004-08-27 | GP; G1 | 6734.72h | 6734.72h | SAIC | Cingular | Marc Grant | Rel-6 | Paolo | SAIC |  |
| 7823 | 2430 | **Enhancement of dialled service for CAMEL** |  | 199d | 2003-03-28 A | 2003-12-31 A | 100% |  | 2003-03-28 | 2003-12-31 | 199d |  |  | S1; N2; N4 | 7960h | 7960h | EDCAMEL | Samsung | craig.bishop@samsung.com | Rel-6 | Alain | EDCAMEL |  |
| 7824 | 2430.1 | Stages 2 and 3 for Enhancement of dialled service for CAMEL |  | 199d | 2003-03-28 A | 2003-12-31 A | 100% |  | 2003-03-28 | 2003-12-31 | 199d |  | finish no earlier than 2003-09-19 | N2; N4 | 3184h | 3184h |  | Samsung | Richard Brook | Rel-6 | Kimmo |  |  |
| 7825 | 2431 | Study on Bandwidth and resource savings in CS networks |  | 273d? | 2003-06-01 A | 2004-06-16 A | 100% |  | 2003-06-01 | 2004-06-16 | 273d? |  | finish no earlier than 2004-06-16 | S2 | 2184h | 2184h | BARS |  |  | Rel-6 | Maurice | BARS |  |
| 7826 | 2432 | **Multiple TBF in A/Gb mode** |  | 736d? | 2002-04-05 A | 2005-01-28 A | 100% |  | 2002-04-05 | 2005-01-28 | 736d? |  |  | GP; G2 | 35200h | 35200h | MULTBF | Ericsson | gunnar.mildh@era.ericsson.se | Rel-6 | Paolo | MULTBF |  |
| 7827 | 2432.1 | **Multiple TBF in A/Gb mode - Core** |  | 366d? | 2002-04-05 A | 2003-08-29 A | 100% |  | 2002-04-05 | 2003-08-29 | 366d? |  |  | GP; G2 | 23424h | 23424h | MULTBF-Agbmode | Ericsson | gunnar.mildh@era.ericsson.se | Rel-6 | Paolo | MULTBF-Agbmode |  |
| 7828 | 2432.1.1 | Multiple TBF Concept paper |  | 366d? | 2002-04-05 A | 2003-08-29 A | 100% |  | 2002-04-05 | 2003-08-29 | 366d? |  | finish no earlier than 2003-08-29 | GP; G2 | 5856h | 5856h |  |  |  | Rel-6 | Paolo |  |  |
| 7829 | 2432.1.2 | Multiple TBF Stage 2 (43.064) CRs |  | 366d? | 2002-04-05 A | 2003-08-29 A | 100% |  | 2002-04-05 | 2003-08-29 | 366d? |  | finish no earlier than 2003-08-29 | GP; G2 | 5856h | 5856h |  |  |  | Rel-6 | Paolo |  |  |
| 7830 | 2432.1.3 | Multiple TBF Stage 3 (44.060) CRs |  | 366d? | 2002-04-05 A | 2003-08-29 A | 100% |  | 2002-04-05 | 2003-08-29 | 366d? |  | finish no earlier than 2003-08-29 | GP; G2 | 5856h | 5856h |  |  |  | Rel-6 | Paolo |  |  |
| 7831 | 2432.2 | Deleted - Multiple TBF in A/Gb mode – MS testing | milestone | 0d? | 2005-01-28 A | 2005-01-28 A | 100% |  | 2005-01-28 | 2005-01-28 | 0d? |  | start no earlier than 2005-01-28 | G3new |  |  | MULTBF-Testing | Ericsson | gunnar.mildh@era.ericsson.se | Rel-6 | Paolo | MULTBF-Testing | GP-27 |
| 7832 | 2433 | **Alignment between the test-regimes for GERAN capable MS** |  | 526d? | 2003-08-29 A | 2005-09-02 | 99% | 0d? | 2003-08-29 | 2005-09-02 | 526d? | 0d |  | G3new | 4208h | 4208h | ALTERE | Ericsson | anthony.toubassi@sonyericsson.com | Rel-6 | Ingbert | ALTERE |  |
| 7833 | 2433.1 | Determine the controversial test cases in the different test regimes and align them with 3GPP GERAN test specifications. Such test cases to be added to TS 51.010. |  | 526d? | 2003-08-29 A | 2005-09-02 A | 100% |  | 2003-08-29 | 2005-09-02 | 526d? |  | finish no earlier than 2005-09-02 | G3new | 4208h | 4208h | ALTERE-TC |  |  | Rel-6 | Ingbert | ALTERE-TC |  |
| 7834 | 2434 | Addition of U-TDOA in the CS domain |  | 111d? | 2003-11-21 A | 2004-04-23 A | 100% |  | 2003-11-21 | 2004-04-23 | 111d? |  | finish no earlier than 2004-04-23 | GP | 888h | 888h | UTDOACS | TruePosition | Bob Gross, Rhys Robinson (rlgross@trueposition.com) | Rel-6 | Paolo | UTDOACS |  |
| 7835 | 2435 | Addition of U-TDOA in the PS domain |  | 361d? | 2003-06-27 A | 2004-11-12 A | 100% |  | 2003-06-27 | 2004-11-12 | 361d? |  | finish no earlier than 2004-11-12 | GP | 2888h | 2888h | UTDOAPS | TruePosition | Bob Gross, Rhys Robinson (rlgross@trueposition.com) | Rel-6 | Paolo | UTDOAPS |  |

Notes:
- 7811: -
- 7812: - / Impacted TSs and TRs: 31.101; 31.102; 31.103; 31.111; 31.113; new 31.115; 31.116
- 7813: -
- 7814: -
- 7815: - / Impacted TSs and TRs: 31.124
- 7816: -
- 7817: 2nd resp SA4 / Impacted TSs and TRs: 22.233
- 7818: TR tbc by Sept. 05 / Impacted TSs and TRs: 26.233; 26.234; 26.244; 26.245; 26.246; 26.401; 26.402; 26.403; 26.404; 26.405; 26.406; 26.410; 26.411; 26.412; 26.273; 26.290; 26.304; 26.412; 26.274; 26.936
- 7819: TR tbc by Sept. 05 / Impacted TSs and TRs: 26.290; 26.304; 26.273; 26.274; 26.412; 26.936
- 7820: - / Impacted TSs and TRs: 26.235; 26.236
- 7821: - / Impacted TSs and TRs: 26.111; 26.911
- 7822: - / Impacted TSs and TRs: 45.903
- 7823: - / Impacted TSs and TRs: 22.078
- 7824: - / Impacted TSs and TRs: 23.008; 23.016; 23.018; 23.078; 29.002; 29.078
- 7825: - / Impacted TSs and TRs: 23.977
- 7826: GP#17 Nov 2003 Moved from Rel-5 UID_50058 MULTBF (Only Multiple TBF Concept paper produced in Rel-5)
- 7827: -
- 7828: -
- 7829: -
- 7830: -
- 7831: -
- 7832: -
- 7833: -
- 7834: Completed, except for potential LMU performance specs
- 7835: -

| ID | WBS | Task | Type | Duration | Start | Finish | Complete | Baseline start | Baseline finish | Baseline duration | Constraint | Resources | Work | Actual work | Acronym | WI rapporteur name | WI rapporteur e-mail | Release | MCC resp | Acronym_3GU_Export | TSG stopped | Impacted TSs and TRs | Created at |
| --- | --- | --- | --- | --- | --- | --- | --- | --- | --- | --- | --- | --- | --- | --- | --- | --- | --- | --- | --- | --- | --- | --- | --- |
| 7836 | 2436 | **Downlink Advanced Receiver Performance** |  | 466d? | 2003-11-21 A | 2005-09-02 A | 100% | 2003-11-21 | 2005-09-02 | 466d? |  | GP | 19160h | 19160h | DARP | Nokia | tommy.bysted@nokia.com | Rel-6 | Paolo | DARP |  |  |  |
| 7837 | 2436.1 | DARP test scenarios |  | 201d? | 2003-11-21 A | 2004-08-27 A | 100% | 2003-11-21 | 2004-08-27 | 201d? | finish no earlier than 2004-08-27 | GP | 1608h | 1608h | DARP-TS | Nokia | tommy.bysted@nokia.com | Rel-6 | Paolo | DARP-TS |  |  |  |
| 7838 | 2436.2 | **DARP for GMSK modulated voice services** |  | 201d? | 2004-02-06 A | 2004-11-12 A | 100% | 2004-02-06 | 2004-11-12 | 201d? |  | GP | 4824h | 4824h | DARP-GMSK | Nokia | tommy.bysted@nokia.com | Rel-6 | Paolo | DARP-GMSK |  |  |  |
| 7839 | 2436.2.1 | Performance requirements in 45.005 for DARP for GMSK modulated voice services |  | 201d? | 2004-02-06 A | 2004-11-12 A | 100% | 2004-02-06 | 2004-11-12 | 201d? | finish no earlier than 2004-11-12 | GP | 1608h | 1608h | DARP-GMSK-Perf |  |  | Rel-6 | Paolo | DARP-GMSK-Perf |  |  |  |
| 7840 | 2436.2.2 | Radio subsystem link control in 45.008 for DARP for GMSK modulated voice services |  | 201d? | 2004-02-06 A | 2004-11-12 A | 100% | 2004-02-06 | 2004-11-12 | 201d? | finish no earlier than 2004-11-12 | GP | 1608h | 1608h | DARP-GMSK-LC |  |  | Rel-6 | Paolo | DARP-GMSK-LC |  |  |  |
| 7841 | 2436.3 | **DARP for GPRS and EGPRS MCS1-MCS4** |  | 201d? | 2004-02-06 A | 2004-11-12 A | 100% | 2004-02-06 | 2004-11-12 | 201d? |  | GP | 4824h | 4824h | DARP-GPRSE | Nokia | tommy.bysted@nokia.com | Rel-6 | Paolo | DARP-GPRSE |  |  |  |
| 7842 | 2436.3.1 | Performance requirements in 45.005 for DARP for GPRS and EGPRS MCS1-MCS4 |  | 201d? | 2004-02-06 A | 2004-11-12 A | 100% | 2004-02-06 | 2004-11-12 | 201d? | finish no earlier than 2004-11-12 | GP | 1608h | 1608h | DARP-GPRSE-Perf |  |  | Rel-6 | Paolo | DARP-GPRSE-Perf |  |  |  |
| 7843 | 2436.3.2 | Radio subsystem link control in 45.008 for DARP for GPRS and EGPRS MCS1-MCS4 |  | 201d? | 2004-02-06 A | 2004-11-12 A | 100% | 2004-02-06 | 2004-11-12 | 201d? | finish no earlier than 2004-11-12 | GP | 1608h | 1608h | DARP-GPRSE-LC |  |  | Rel-6 | Paolo | DARP-GPRSE-LC |  |  |  |
| 7844 | 2436.4 | DARP Capability signalling |  | 256d? | 2003-11-21 A | 2004-11-12 A | 100% | 2003-11-21 | 2004-11-12 | 256d? | finish no earlier than 2004-11-12 | GP | 2048h | 2048h | DARP-CAPSIG | Nokia | tommy.bysted@nokia.com | Rel-6 | Paolo | DARP-CAPSIG |  |  |  |
| 7845 | 2436.5 | GERAN MS Conformance test for DARP |  | 266d? | 2004-08-27 A | 2005-09-02 A | 100% | 2004-08-27 | 2005-09-02 | 266d? | finish no earlier than 2005-06-24 | G3new | 2128h | 2128h | ARP-ConfTest | Nokia | tommy.bysted@nokia.com | Rel-6 | Ingbert | ARP-ConfTest |  |  |  |
| 7846 | 2437 | **Reduction of PS service interruption in Dual Transfer Mode** |  | 416d? | 2003-11-21 A | 2005-06-24 A | 100% | 2003-11-21 | 2005-06-24 | 416d? |  | G2 | 8360h | 8360h | PSintDTM | Siemens | toby.proctor@roke.co.uk | Rel-6 | Gert | PSintDTM |  |  |  |
| 7847 | 2437.1 | Use case and requirement definition |  | 111d? | 2003-11-21 A | 2004-04-23 A | 100% | 2003-11-21 | 2004-04-23 | 111d? | finish no earlier than 2004-04-23 | G2 | 888h | 888h | PSintDTM-Req | Siemens | toby.proctor@roke.co.uk | Rel-6 | Gert | PSintDTM-Req |  |  |  |
| 7848 | 2437.2 | Performance Study of Current Procedures |  | 111d? | 2003-11-21 A | 2004-04-23 A | 100% | 2003-11-21 | 2004-04-23 | 111d? | start no earlier than 2003-11-21 | G2 | 888h | 888h | PSintDTM-Perf | Siemens | toby.proctor@roke.co.uk | Rel-6 | Gert | PSintDTM-Perf |  |  |  |
| 7849 | 2437.3 | Reduction of service interruption times and packet loss during Dual Transfer Mode and mobility procedures |  | 146d? | 2004-04-23 A | 2004-11-12 A | 100% | 2004-04-23 | 2004-11-12 | 146d? | finish no earlier than 2004-11-12 | G2 | 1168h | 1168h | PSintDTM-Reduct | Siemens | toby.proctor@roke.co.uk | Rel-6 | Gert | PSintDTM-Reduct |  |  |  |
| 7850 | 2437.4 | Deleted - MS Conformance testing - Reduction of PS service interruption in DTM |  | 261d? | 2004-06-25 A | 2005-06-24 A | 100% | 2004-06-25 | 2005-06-24 | 261d? | finish no earlier than 2005-06-24 | G3new | 2088h | 2088h | PSintDTM-ConfMS |  |  | Rel-6 | Ingbert | PSintDTM-ConfMS | GP-25 |  |  |
| 7851 | 2437.5 | Deleted - BTS Conformance testing - Reduction of PS service interruption in DTM | milestone | 0d? | 2005-06-24 A | 2005-06-24 A | 100% | 2005-06-24 | 2005-06-24 | 0d? | finish no earlier than 2005-06-24 | G3new |  |  | PSintDTM-ConfBTS |  |  | Rel-6 | Ingbert | PSintDTM-ConfBTS | GP-25 |  |  |
| 7852 | 2438 | CAMEL prepay interworking with SCUDIF |  | 216.3d | 2003-12-08 A | 2004-10-05 A | 100% | 2003-12-08 | 2004-10-05 | 216.3d |  | N4; N3; S1 | 5191.2h | 5191.2h | SCCAMEL | Nokia | Keijo.Palviainen@Nokia.Com | Rel-6 | Kimmo | SCCAMEL |  | 22.078; 23.078; 29.078; 29.002; 23.172 |  |
| 7853 | 2439 | **Circuit Switched Video and Voice Service Improvements** |  | 430d? | 2004-01-12 A | 2005-09-02 A | 100% | 2004-01-12 | 2005-09-02 | 430d? |  | S2; N1 | 12696h | 12696h | CS_VSS | Vodafone | John Watson | Rel-6 | Alain | CS_VSS |  |  |  |
| 7854 | 2439.1 | Deleted - Stage 1 - Requirements |  | 199d | 2004-01-12 A | 2004-10-14 A | 100% | 2004-01-12 | 2004-10-14 | 199d | finish no earlier than 2004-10-14 | S1 | 1592h | 1592h |  | Vodafone | John Watson | Rel-6 | Alain |  | SP-26 | 22.101 |  |
| 7855 | 2439.2 | Stage 2 Study on architecture alternatives |  | 244d? | 2004-01-12 A | 2004-12-16 A | 100% | 2004-01-12 | 2004-12-16 | 244d? | finish no earlier than 2004-08-13 | S2 | 1952h | 1952h |  | Vodafone | chris.pudney@vodafone.com | Rel-6 | Maurice |  |  | 23.903 | SP-24 |
| 7856 | 2439.3 | Deleted - Stage 2 description on Redial |  | 164d? | 2004-05-03 A | 2004-12-16 A | 100% | 2004-05-03 | 2004-12-16 | 164d? | finish no earlier than 2004-12-16 | S2 | 1312h | 1312h |  | Vodafone | chris.pudney@vodafone.com | Rel-6 | Maurice |  | SP-26 |  | SP-24 |
| 7857 | 2439.4 | Switching between voice and video call - Redial solution |  | 120d? | 2005-01-03 A | 2005-06-17 A | 100% | 2005-01-03 | 2005-06-17 | 120d? | start no earlier than 2005-01-03 | N1 | 960h | 960h |  | Vodafone |  | Rel-6 | Frederic |  |  | 23.009; 24.008 |  |
| 7858 | 2439.5 | Deleted - CS_VSS - GERAN2 Part | milestone | 0d | 2005-09-02 A | 2005-09-02 A | 100% | 2005-09-02 | 2005-09-02 | 0d | start no earlier than 2005-09-02 | G2 |  |  |  | Vodafone |  | Rel-6 | Gert |  | GP-26 |  |  |
| 7859 | 2439.6 | Deleted - CS_VSS - CN3 Part | milestone | 0d? | 2004-10-14 A | 2004-10-14 A | 100% | 2004-10-14 | 2004-10-14 | 0d? | start no earlier than 2004-10-14 | N3 |  |  |  | Vodafone |  | Rel-6 | Gwiho |  | TP-26 |  |  |
| 7860 | 2440 | Reorganisation of CS Data Specifications |  | 14d? | 2004-11-19 A | 2004-12-08 A | 100% | 2004-11-19 | 2004-12-08 | 14d? | finish no earlier than 2004-12-24 | N3 | 112h | 112h | CSData | Siemens | Thomas.Belling@nsn.com | Rel-6 | Gwiho | CS Data |  | 23.910; 29.007; New 23.202 |  |

Notes:
- 7836: -
- 7837: -
- 7838: -
- 7839: -
- 7840: -
- 7841: -
- 7842: -
- 7843: -
- 7844: -
- 7845: -
- 7846: -
- 7847: -
- 7848: -
- 7849: -
- 7850: -
- 7851: -
- 7852: -
- 7853: -
- 7854: -
- 7855: -
- 7856: -
- 7857: -
- 7858: -
- 7859: -
- 7860: Created at TSG#27 as 100 % complete

| ID | WBS | Task | Type | Duration | Start | Finish | Complete | Baseline start | Baseline finish | Baseline duration | Constraint | Resources | Work | Actual work | Acronym | WI rapporteur name | Release | MCC resp | Acronym_3GU_Export | Impacted TSs and TRs | WI rapporteur e-mail | TSG stopped |
| --- | --- | --- | --- | --- | --- | --- | --- | --- | --- | --- | --- | --- | --- | --- | --- | --- | --- | --- | --- | --- | --- | --- |
| 7861 | 2441 | **Generic Access to A/Gb Interface (GAAI)** |  | 411d? | 2004-06-25 A | 2006-01-20 A | 100% | 2004-06-25 | 2006-01-20 | 411d? |  | GP | 9160h | 9160h | GAAI | Motorola | Rel-6 | Paolo | GAAI |  |  |  |
| 7862 | 2441.1 | FS on GAAI |  | 46d? | 2004-06-25 A | 2004-08-27 A | 100% | 2004-06-25 | 2004-08-27 | 46d? | finish no earlier than 2004-08-27 | GP | 368h | 368h | GAAG | Motorola | Rel-6 | Paolo | GAAG | 43.901 |  |  |
| 7863 | 2441.2 | GAAI – Stage 2 |  | 161d? | 2004-08-27 A | 2005-04-08 A | 100% | 2004-08-27 | 2005-04-08 | 161d? | finish no earlier than 2005-04-08 | GP | 1288h | 1288h | GAAI-Stage2 | Ericsson | Rel-6 | Paolo | GAAI-Stage2 | 43.318 | jari.vikberg@ericsson.com |  |
| 7864 | 2441.3 | GAAI – Stage 3 |  | 161d? | 2004-08-27 A | 2005-04-08 A | 100% | 2004-08-27 | 2005-04-08 | 161d? | finish no earlier than 2005-04-08 | GP | 1288h | 1288h | GAAI-Stage3 |  | Rel-6 | Paolo | GAAI-Stage3 | 44.318 |  |  |
| 7865 | 2441.4 | MS Conformance Test for GAAI |  | 366d? | 2004-08-27 A | 2006-01-20 A | 100% | 2004-08-27 | 2006-01-20 | 366d? | finish no earlier than 2006-01-20 | GP | 2928h | 2928h | GAAI-CT |  | Rel-6 | Ingbert | GAAI-CT |  |  |  |
| 7866 | 2442 | **Support of PS Handover for GERAN A/Gb mode** |  | 473d? | 2003-11-03 A | 2005-08-24 A | 100% | 2003-11-03 | 2005-08-24 | 473d? |  | GP; G2 | 30272h | 30272h | SPSHAGB | Ericsson | Rel-6 | Paolo | SPSHAGB |  | gunnar.hedby@ericsson.com |  |
| 7867 | 2442.1 | Stage 2 for Support of PS Handover for GERAN A/Gb mode |  | 473d? | 2003-11-03 A | 2005-08-24 A | 100% | 2003-11-03 | 2005-08-24 | 473d? | finish no earlier than 2005-09-02 | GP; G2 | 7568h | 7568h | SPSHAGB-Stage2 | Ericsson | Rel-6 | Paolo | SPSHAGB-Stage2 | 43.129 | gunnar.hedby@ericsson.com |  |
| 7868 | 2442.2 | PS handover for Support of PS Handover for GERAN A/Gb mode |  | 473d? | 2003-11-03 A | 2005-08-24 A | 100% | 2003-11-03 | 2005-08-24 | 473d? | finish no earlier than 2005-09-02 | GP; G2 | 7568h | 7568h | SPSHAGB-PSHO | Ericsson | Rel-6 | Paolo | SPSHAGB-PSHO |  | gunnar.hedby@ericsson.com |  |
| 7869 | 2442.3 | Definition of radio resource management functionality for Support of PS Handover for GERAN A/Gb mode |  | 473d? | 2003-11-03 A | 2005-08-24 A | 100% | 2003-11-03 | 2005-08-24 | 473d? | finish no earlier than 2005-09-02 | GP; G2 | 7568h | 7568h | SPSHAGB-RRM | Ericsson | Rel-6 | Paolo | SPSHAGB-RRM |  | gunnar.hedby@ericsson.com |  |
| 7870 | 2443 | Study on (U)SIM Security Reuse by Peripheral Devices on Local Interfaces |  | 127d? | 2003-07-03 A | 2003-12-26 A | 100% | 2003-07-03 | 2003-12-26 | 127d? | finish no earlier than 2003-12-26 | S3 | 1016h | 1016h |  | Toshiba | Rel-6 | Mirko |  | 33.817 | Raziq Yaqub (ryaqub@tari.toshiba.com) |  |
| 7871 | 2444 | Study on Security for early IMS |  | 127d? | 2004-10-01 A | 2005-03-28 A | 100% | 2004-10-01 | 2005-03-28 | 127d? | finish no earlier than 2003-12-26 | S3 | 1016h | 1016h | SEC-IMS | Vodafone | Rel-6 | Mirko | SEC-IMS | 33.978 | Peter.Howard@vodafone.com |  |
| 7872 | 2445 | (Small) Technical Enhancements and Improvements for Rel-6 | milestone | 0d? | 2006-06-02 A | 2006-06-02 A | 100% | 2006-06-02 | 2006-06-02 | 0d? |  | SP; CP; RP; GP |  |  | TEI6 |  | Rel-6 | all | TEI6 |  |  |  |
| 7873 | 2446 | Test - (Small) Technical Enhancements and Improvements for Rel-6 |  | 503d? | 2006-06-02 A | 2008-05-06 A | 100% | 2006-06-02 | 2008-05-06 | 503d? | start no earlier than 2006-06-02 | R5; T1 | 8048h | 8048h | TEI6_Test |  | Rel-6 | Ingbert | TEI6_Test | 34.108.34.121-1/2.34.122.34.123-1/2/3 |  |  |
| 7874 | 2447 | Deleted - Study of Feature Interactions Requirements | milestone | 0d? | 2004-09-16 A | 2004-09-16 A | 100% | 2004-09-16 | 2004-09-16 | 0d? | finish no earlier than 2004-10-01 | S1 |  |  | FINTER |  | Rel-6 | Alain | FINTER |  |  | SP-25 |
| 7875 | 2448 | Deleted EVGCS - Enhancements of VGCS in public networks for communication of public authority officials |  | 7d? | 2005-08-25 A | 2005-09-02 A | 100% | 2005-08-25 | 2005-09-02 | 7d? | start no earlier than 2005-08-24 | GP; G2 | 112h | 112h |  | Siemens | Rel-6 | Paolo |  | 44.018; 44.068; 48.008 | kenneth.isaacs@roke.co.uk | GP-26 |
| 7876 | 2449 | **Deleted SCSAGB - Support of Conversational Services in A/Gb mode via the PS domain** |  | 64d? | 2003-11-21 A | 2004-02-19 A | 100% | 2003-11-21 | 2004-02-19 | 64d? |  | GP; N1 | 2048h | 2048h |  | Ericsson | Rel-6 | Paolo |  |  | David Bladsjö (david.bladsjo@ericsson.com) | GP-18 |
| 7877 | 2449.1 | Deleted - Creation of a TR | milestone | 0d? | 2003-11-21 A | 2003-11-21 A | 100% | 2003-11-21 | 2003-11-21 | 0d? | start no earlier than 2003-11-21 | GP |  |  | SCSAGB-TR | Ericsson | Rel-6 | Paolo | SCSAGB-TR |  | David Bladsjö (david.bladsjo@ericsson.com) | GP-17 |
| 7878 | 2449.2 | Deleted - Stage 2 | milestone | 0d? | 2003-11-21 A | 2003-11-21 A | 100% | 2003-11-21 | 2003-11-21 | 0d? | finish no earlier than 2003-11-21 | GP |  |  | SCSAGB-Stage2 | Ericsson | Rel-6 | Paolo | SCSAGB-Stage2 |  | David Bladsjö (david.bladsjo@ericsson.com) | GP-17 |
| 7879 | 2449.3 | Deleted - Radio Channel Support | milestone | 0d? | 2003-11-21 A | 2003-11-21 A | 100% | 2003-11-21 | 2003-11-21 | 0d? | finish no earlier than 2003-11-21 | GP |  |  | SCSAGB-RCS | Ericsson | Rel-6 | Paolo | SCSAGB-RCS |  | David Bladsjö (david.bladsjo@ericsson.com) | GP-17 |
| 7880 | 2449.4 | Deleted SCSAGB-RRM - Definition of radio resource management functionality | milestone | 0d? | 2003-11-21 A | 2003-11-21 A | 100% | 2003-11-21 | 2003-11-21 | 0d? | finish no earlier than 2003-11-21 | GP |  |  |  | Ericsson | Rel-6 | Paolo |  |  | David Bladsjö (david.bladsjo@ericsson.com) | GP-17 |
| 7881 | 2449.5 | Deleted - replaced by 50561 - PS Handover |  | 64d | 2003-11-24 A | 2004-02-19 A | 100% | 2003-11-24 | 2004-02-19 | 64d | start no earlier than 2003-11-21 | GP; N1 | 1024h | 1024h | SCSAGB-PSH | Ericsson | Rel-6 | Paolo | SCSAGB-PSH |  | David Bladsjö (david.bladsjo@ericsson.com) | GP-18 |
| 7882 | 2449.6 | Deleted SCSAGB-FLO - Modifications to FLO | milestone | 0d? | 2003-11-21 A | 2003-11-21 A | 100% | 2003-11-21 | 2003-11-21 | 0d? | finish no earlier than 2003-11-21 | GP |  |  |  | Ericsson | Rel-6 | Paolo |  |  | David Bladsjö (david.bladsjo@ericsson.com) | RP-29 |
| 7883 | 2450 | Deleted - Rel-6 Evolutions of the transport in the UTRAN (ETRAN) | milestone | 0d | 2003-12-31 A | 2003-12-31 A | 100% | 2003-12-31 | 2003-12-31 | 0d | start no earlier than 2003-12-31 | RP |  |  |  | Alcatel | Rel-6 | Issam |  |  | Francois Courau | RP-22 |
| 7884 | 2451 | --- RELEASE 5 --- |  | 325d? | 2000-01-03 A | 2001-03-29 A | 100% | 2000-01-03 | 2001-03-29 | 325d? |  | NP; GP; RP; SP; TP | 13000h | 13000h |  |  | Rel-5 | All |  |  |  |  |
| 7885 | 75 | IP transport in the UTRAN |  | 445d | 2000-07-17 A | 2002-03-29 A | 100% | 2000-07-17 | 2002-03-29 | 445d | finish no earlier than 2002-03-29 | R3 | 3560h | 3560h | ETRAN-IPtrans | Alcatel | Rel-5 | Juha | ETRAN-IPtrans |  | Nicolas Drevon |  |
| 7886 | 76 | Feasibility study on SS7 signalling transportation in the core network with SCCP-User Adaptation (SUA) |  | 205d | 2001-03-12 A | 2001-12-21 A | 100% | 2001-03-12 | 2001-12-21 | 205d | finish no earlier than 2001-12-21 | N4 | 1640h | 1640h | FS_SS7IP |  | Rel-5 | Kimmo | FS_SS7IP | 29.903 |  |  |

Notes:
- 7861: -
- 7862: Feasibility Study
- 7863: -
- 7864: -
- 7865: Marked as closed 12/2008 (was marked 90% complete)
- 7866: Replaces SCSAGB- Originally Started Nov 2003 as GP-030443
- 7867: Replaces SCSAGB-Stage2
- 7868: Replaces SCSAGB-PSH
- 7869: Replaces SCSAGB-RRM
- 7870: SP#20 approved WID
- 7871: SP#24 approved WID. SP#46 withdrawn TR 33.978 from Rel-8 onwards
- 7872: "Joker" WI, to be used for a Rel 6 CR not related to any feature and with very limited impact on the system. Moved in from Stoyan/Testing WP
- 7873: "Joker" WI, to be used for small modifications applicable to Rel 4 conformance testing
- 7874: SP#25 stopped
- 7875: GP#26 moved to Rel-7 as UID_11045 Enhancements of VGCS in public networks for communication of public authority officials
- 7876: -
- 7877: -
- 7878: Started
- 7879: Not started
- 7880: Not started
- 7881: Started
- 7882: Not started
- 7883: Generic feature ETRAN
- 7884: -
- 7885: -
- 7886: -

| ID | WBS | Task | Duration | Start | Finish | Complete | Baseline start | Baseline finish | Baseline duration | Constraint | Deadline | Resources | Work | Actual work | Acronym | WI rapporteur name | WI rapporteur e-mail | Release | MCC resp | Acronym_3GU_Export | Impacted TSs and TRs | Created at | TSG stopped |
| --- | --- | --- | --- | --- | --- | --- | --- | --- | --- | --- | --- | --- | --- | --- | --- | --- | --- | --- | --- | --- | --- | --- | --- |
| 7887 | 77 | **High Speed Downlink Packet Access** | 1550d? | 2001-04-02 A | 2007-03-09 A | 100% | 2001-04-02 | 2007-03-09 | 1550d? |  |  | R2; R5 | 43888h | 43888h | HSDPA | Motorola | Ravi Kuchibhotla | Rel-5 | Yong-Jun | HSDPA |  |  |  |
| 7888 | 77.1 | Physical Layer for High Speed Downlink Packet Access | 257d | 2001-04-05 A | 2002-03-29 A | 100% | 2001-04-05 | 2002-03-29 | 257d | finish no earlier than 2002-03-29 |  | R1 | 2056h | 2056h | HSDPA-Phys | Motorola | Amitabha Ghosh (qa0047@email.mot.com) | Rel-5 | Patrick | HSDPA-Phys |  |  |  |
| 7889 | 77.2 | Layer 2 and 3 aspects | 257d | 2001-04-05 A | 2002-03-29 A | 100% | 2001-04-05 | 2002-03-29 | 257d | finish no earlier than 2002-03-29 |  | R2 | 2056h | 2056h | HSDPA-L23 | Motorola | Ravi Kuchibhotla | Rel-5 | Yong-Jun | HSDPA-L23 |  |  |  |
| 7890 | 77.3 | Iub/Iur protocol aspects - for High Speed Downlink Packet Access | 260d | 2001-04-02 A | 2002-03-29 A | 100% | 2001-04-02 | 2002-03-29 | 260d | finish no earlier than 2002-03-29 |  | R3 | 2080h | 2080h | HSDPA-IubIur | Motorola | Mike Diesen | Rel-5 | Juha | HSDPA-IubIur |  |  |  |
| 7891 | 77.4 | RF Radio Transmission/ Reception, System Performance Requirements and Conformance Testing | 565d | 2001-04-09 A | 2003-06-06 A | 100% | 2001-04-09 | 2003-06-06 | 565d | finish no earlier than 2003-06-06 |  | R4 | 4520h | 4520h | HSDPA-RF | Motorola | Howard Benn | Rel-5 | Issam | HSDPA-RF |  |  |  |
| 7892 | 2454.5 | Conformance Testing of HSDPA | 786d | 2003-09-19 A | 2006-09-22 A | 100% | 2003-09-19 | 2006-09-22 | 786d | finish no earlier than 2006-09-22 |  | R5 | 6288h | 6288h | HSDPA_Test | Motorola | carolyn.taylor@motorola.com | Rel-5 | Ingbert | HSDPA_Test | 34.108; 34.121; 34.122; 34.123-1; 34.123-2; 34.123-3 | 19/9/2003 |  |
| 7893 | 2454.6 | Conformance Testing of HCR TDD HSDPA | 261d? | 2006-03-10 A | 2007-03-09 A | 100% | 2006-03-10 | 2007-03-09 | 261d? | finish no earlier than 2007-03-09 |  | R5 | 2088h | 2088h | HSDPA_HCRTDD_Test | IPWireless | drichards@ipwireless.com | Rel-5 | Ingbert | HSDPA_HCRTDD_Test | 34.108; 34.122; 34.123-1; 34.123-2; 34.123-3 |  |  |
| 7894 | 78 | **Rel-5 Improvements of Radio Interface** | 535d | 2000-08-14 A | 2002-08-30 A | 100% | 2000-08-14 | 2002-08-30 | 535d |  |  | RP | 30376h | 30376h |  |  |  | Rel-5 |  |  |  |  |  |
| 7895 | 78.1 | **Base station classification for TDD** | 480d | 2000-08-14 A | 2002-06-14 A | 100% | 2000-08-14 | 2002-06-14 | 480d |  |  | R4 | 9208h | 9208h | RInImp-BSClass | Nokia | antti.toskala@nokia.com | Rel-5 | Issam | RInImp-BSClass |  |  |  |
| 7896 | 78.1.1 | TDD Base station classification | 410d | 2000-08-14 A | 2002-03-08 A | 100% | 2000-08-14 | 2002-03-08 | 410d | finish no earlier than 2002-03-08 |  | R4 | 3280h | 3280h | RInImp-BSClass-TDD | Nokia | antti.toskala@nokia.com | Rel-5 | Issam | RInImp-BSClass-TDD |  |  |  |
| 7897 | 78.1.2 | Base Station Classification for 1.28 Mcps TDD option | 261d | 2001-06-15 A | 2002-06-14 A | 100% | 2001-06-15 | 2002-06-14 | 261d | finish no earlier than 2002-06-14 |  | R4 | 2088h | 2088h | RInImp-BSClass-LCRTDD | Siemens | Meik.Kottkamp@siemens.com | Rel-5 | Issam | RInImp-BSClass-LCRTDD |  |  |  |
| 7898 | 78.2 | Enhancement on the DSCH hard split mode | 271d | 2001-03-16 A | 2002-03-29 A | 100% | 2001-03-16 | 2002-03-29 | 271d | finish no earlier than 2002-03-29 |  | R1 | 2168h | 2168h | RInImp-DSCHhsp | Samsung | Jaeyoel KIM | Rel-5 | Patrick | RInImp-DSCHhsp |  |  |  |
| 7899 | 78.3 | Hybrid ARQ II/III | 355d | 2000-08-21 A | 2001-12-28 A | 100% | 2000-08-21 | 2001-12-28 | 355d | finish no earlier than 2001-12-28 |  | R2 | 2840h | 2840h | RInImp-HARQ | Siemens | armin.sitte@siemens.com | Rel-5 | Yong-Jun | RInImp-HARQ |  |  | RP-14 |
| 7900 | 78.4 | FS on USTS | 355d | 2000-08-14 A | 2001-12-21 A | 100% | 2000-08-14 | 2001-12-21 | 355d | finish no earlier than 2001-12-21 |  | R1 | 2840h | 2840h | RInImp-USTS | SK Telecom | D. Kim | Rel-5 | Patrick | RInImp-USTS |  |  |  |
| 7901 | 78.5 | FS on UE antenna efficiency test method performance requirements | 255d | 2000-09-25 A | 2001-09-14 A | 100% | 2000-09-25 | 2001-09-14 | 255d | finish no earlier than 2001-09-14 |  | R4 | 2040h | 2040h | RInImp-UEAnTM | Allgon | O. Edvardsson | Rel-5 | Issam | RInImp-UEAnTM |  |  |  |
| 7902 | 78.6 | FS on the re-introduction of the downlink SIR measurement | 200d | 2001-03-12 A | 2001-12-14 A | 100% | 2001-03-12 | 2001-12-14 | 200d | finish no earlier than 2001-12-14 |  | R4 | 1600h | 1600h | RInImp-SIR | Ericsson | Torgny.Palenius@ericsson.com | Rel-5 | Issam | RInImp-SIR |  |  |  |
| 7903 | 78.7 | FS on mitigating the effect of CPICH interference at the UE | 255d | 2001-03-19 A | 2002-03-08 A | 100% | 2001-03-19 | 2002-03-08 | 255d | finish no earlier than 2002-03-08 |  | R4 | 2040h | 2040h | RInImp-CPICH_Intf | Intel | shimon.moshavi@INTEL.COM | Rel-5 | Issam | RInImp-CPICH_Intf |  |  |  |
| 7904 | 78.8 | **Deleted - Conformance Test Spec. improvements in Radio Interface** | 140d | 2002-02-18 A | 2002-08-30 A | 100% | 2002-02-18 | 2002-08-30 | 140d |  |  | T1 | 3360h | 3360h |  |  |  | Rel-5 | Ingbert |  |  |  | TP-17 |
| 7905 | 78.8.1 | Deleted - Testing improvement of inter-frequency and inter-system measurement | 140d | 2002-02-18 A | 2002-08-30 A | 100% | 2002-02-18 | 2002-08-30 | 140d | finish no earlier than 2002-08-30 |  | T1 | 1120h | 1120h |  |  |  | Rel-5 | Ingbert |  |  |  | TP-17 |
| 7906 | 78.8.2 | Deleted - Testing Hybrid ARQ II/III | 140d | 2002-02-18 A | 2002-08-30 A | 100% | 2002-02-18 | 2002-08-30 | 140d | finish no earlier than 2002-08-30 |  | T1 | 1120h | 1120h |  |  |  | Rel-5 | Ingbert |  |  |  | TP-17 |
| 7907 | 79 | **Rel-5 RAN improvements** | 1561d? | 2001-03-16 A | 2007-03-09 A | 100% | 2001-03-16 | 2007-03-09 | 1561d? |  |  | RP | 49424h | 49424h |  |  |  | Rel-5 |  |  |  |  |  |
| 7908 | 79.1 | **RRM optimization for Iur and Iub** | 318d | 2001-03-16 A | 2002-06-04 A | 100% | 2001-03-16 | 2002-06-04 | 318d |  |  | R3 | 8904h | 8904h | RANimp-RRMopt | Ericsson | Gert-Jan.van.Lieshout@eln.ericsson.se | Rel-5 | Juha | RANimp-RRMopt |  |  |  |
| 7909 | 79.1.1 | Iur common transport channel efficiency optimization | 271d | 2001-03-16 A | 2002-03-29 A | 100% | 2001-03-16 | 2002-03-29 | 271d | finish no earlier than 2002-03-29 |  | R3 | 2168h | 2168h | RANimp-RRMopt-ctc | Ericsson | Shahrokh Amirijoo | Rel-5 | Juha | RANimp-RRMopt-ctc |  |  |  |
| 7910 | 79.1.2 | Iur neighbouring cell reporting efficiency optimization | 271d | 2001-03-16 A | 2002-03-29 A | 100% | 2001-03-16 | 2002-03-29 | 271d | finish no earlier than 2002-03-29 |  | R3 | 2168h | 2168h | RANimp-RRMopt-ncr | Ericsson | Shahrokh Amirijoo | Rel-5 | Juha | RANimp-RRMopt-ncr |  |  |  |
| 7911 | 79.1.3 | FS Introduction of direct transport bearers between SRNC and Node-B | 253d | 2001-06-15 A | 2002-06-04 A | 100% | 2001-06-15 | 2002-06-04 | 253d | finish no earlier than 2002-06-28 |  | R3 | 2024h | 2024h | RAN-imp-RRMopt-DTB | Ericsson | Risto Sepponen | Rel-5 | Juha | RAN-imp-RRMopt-DTB |  |  |  |
| 7912 | 79.2 | RL Timing Adjustment | 271d | 2001-03-16 A | 2002-03-29 A | 100% | 2001-03-16 | 2002-03-29 | 271d | finish no earlier than 2002-03-29 |  | R3 | 2168h | 2168h | RANimp-RLTA | Ericsson | Elena Voltolina | Rel-5 | Juha | RANimp-RLTA |  |  |  |
| 7913 | 79.3 | Separation of resource reservation and radio link activation | 271d | 2001-03-16 A | 2002-03-29 A | 100% | 2001-03-16 | 2002-03-29 | 271d | finish no earlier than 2002-03-29 |  | R3 | 2168h | 2168h | RANimp-SepRR | Ericsson | Gert-Jan.van.Lieshout@eln.ericsson.se | Rel-5 | Juha | RANimp-SepRR |  |  |  |
| 7914 | 79.4 | FS SRNS Relocation Procedure Enhancement | 318d | 2001-06-15 A | 2002-09-03 A | 100% | 2001-06-15 | 2002-09-03 | 318d | finish no earlier than 2002-09-06 |  | R3 | 2544h | 2544h | RANimp-SRNS | Nokia | Olivier Guyot | Rel-5 | Juha | RANimp-SRNS |  |  |  |
| 7915 | 79.5 | FS Improvement of Radio Resource Management across RNS and RNS/PSS | 201d | 2001-03-16 A | 2001-12-21 A | 100% | 2001-03-16 | 2001-12-21 | 201d | finish no earlier than 2001-12-21 |  | R3 | 1608h | 1608h | RANimp-ImpRRM | Nokia | antti.toskala@nokia.com | Rel-5 | Juha | RANimp-ImpRRM |  |  |  |
| 7916 | 79.6 | Re-arrangements of Iub transport bearers | 271d | 2001-03-16 A | 2002-03-29 A | 100% | 2001-03-16 | 2002-03-29 | 271d | finish no earlier than 2002-03-29 |  | R3 | 2168h | 2168h | RANimp-TTPS | Nokia | antti.toskala@nokia.com | Rel-5 | Juha | RANimp-TTPS |  |  |  |
| 7917 | 79.7 | RAB support enhancement for Rel-5 | 325d | 2001-04-02 A | 2002-06-28 A | 100% | 2001-04-02 | 2002-06-28 | 325d |  |  | R2 | 2600h | 2600h | RANimp-RABSE5 | Nokia | Juha Mikola | Rel-5 | Yong-Jun | RANimp-RABSE5 |  |  |  |
| 7918 | 16.5.1 | Testing of ROHC performance | 391d | 2005-09-09 A | 2007-03-09 A | 100% | 2005-09-09 | 2007-03-09 | 391d | finish no earlier than 2007-03-09 | 2006-06-02 | R5 | 3128h | 3128h | RANimp-RABSE5_Test | Nokia | jarkko.hellsten@nokia.com | Rel-5 | Ingbert | RANimp-RABSE5_Test | 34.108; 34.123-1; 34.123-2; 34.123-3 | Fri 11/03/05 |  |
| 7919 | 79.8 | Beamforming requirements for UE | 61d | 2001-09-21 A | 2001-12-14 A | 100% | 2001-09-21 | 2001-12-14 | 61d | finish no earlier than 2001-12-14 |  | R1 | 488h | 488h | RANimp-BFR-UE | Nokia | Jussi Kähtävä (juha.mikola@nokia.com) | Rel-5 | Patrick | RANimp-BFR-UE |  |  |  |
| 7920 | 79.9 | Support of Site Selection Diversity Transmission in UTRAN | 123d | 2001-12-14 A | 2002-06-04 A | 100% | 2001-12-14 | 2002-06-04 | 123d | finish no earlier than 2002-06-04 |  | R1 | 984h | 984h | RANimp-SSDT | NEC |  | Rel-5 | Patrick | RANimp-SSDT |  |  |  |
| 7921 | 79.10 | Node B Synchronisation for 1.28 Mcps TDD | 271d | 2001-03-16 A | 2002-03-29 A | 100% | 2001-03-16 | 2002-03-29 | 271d | finish no earlier than 2002-03-29 |  | R1 | 2168h | 2168h | RANimp-NBSLCR | CATT | Jinling HU | Rel-5 | Patrick | RANimp-NBSLCR |  |  |  |

Notes:
- 7887: -
- 7888: -
- 7889: -
- 7890: -
- 7891: -
- 7892: -
- 7893: -
- 7894: -
- 7895: -
- 7896: -
- 7897: -
- 7898: -
- 7899: Stopped at RP#14¦work on this task was performed as part of High Speed Downlink Packet Access feature
- 7900: -
- 7901: -
- 7902: -
- 7903: -
- 7904: Marked as stopped 12/2008
- 7905: Marked as stopped 12/2008
- 7906: Marked as stopped 12/2008
- 7907: -
- 7908: -
- 7909: -
- 7910: -
- 7911: FS was closed and introduction of WI not agreed at RAN #16
- 7912: -
- 7913: -
- 7914: -
- 7915: FS was closed and WI was introduced at RAN #14
- 7916: -
- 7917: RFC 3095 context relocation
- 7918: -
- 7919: -
- 7920: RP-020356
- 7921: -

| ID | WBS | Task | Duration | Start | Finish | Complete | Baseline start | Baseline finish | Baseline duration | Constraint | Deadline | Resources | Work | Actual work | Release | MCC resp | TSG stopped | Acronym | Impacted TSs and TRs | Acronym_3GU_Export | WI rapporteur name | WI rapporteur e-mail | Created at |
| --- | --- | --- | --- | --- | --- | --- | --- | --- | --- | --- | --- | --- | --- | --- | --- | --- | --- | --- | --- | --- | --- | --- | --- |
| 7922 | 79.12 | **Deleted - Conformance Test Aspects - RAN Improvements** | 565d? | 2002-01-01 A | 2004-03-01 A | 100% | 2002-01-01 | 2004-03-01 | 565d? |  |  | T1 | 8008h | 8008h | Rel-5 | Ingbert | TP-23 |  |  |  |  |  |  |
| 7923 | 79.12.1 | Deleted - Testing Radio access bearer support enhancements | 175d | 2002-01-01 A | 2002-09-02 A | 100% | 2002-01-01 | 2002-09-02 | 175d | finish no earlier than 2002-09-02 |  | T1 | 1400h | 1400h | Rel-5 | Ingbert | TP-17 |  |  |  |  |  |  |
| 7924 | 2456.12.2 | Deleted - General changes to TS34.121 and TS34.122 corresponding to release 5 | 261d? | 2003-03-03 A | 2004-03-01 A | 100% | 2003-03-03 | 2004-03-01 | 261d? | finish no earlier than 2004-03-01 |  | T1 | 2088h | 2088h | Rel-5 | Ingbert | TP-23 | RANimp-test,TEI5 | 34.108; 34.121; 34.122 | RANimp-test, TEI5 |  |  |  |
| 7925 | 80 | UTRAN Sharing in Connected Mode | 197d | 2001-12-03 A | 2002-09-03 A | 100% | 2001-12-03 | 2002-09-03 | 197d | finish no earlier than 2002-09-06 |  | R3 | 1576h | 1576h | Rel-5 | Juha |  | NETSHARE |  | NETSHARE | Ericsson | Martin Israelsson |  |
| 7926 | 81 | **Provisioning of IP-based multimedia services** | 1806d | 2000-01-03 A | 2006-12-01 A | 100% | 2000-01-03 | 2006-12-01 | 1806d |  |  | S1; S2; S3; S5; NP; T3; T1; R5 | 325092h | 325092h | Rel-5 | Alain |  | IMS |  | IMS | Openwave | Mark Cataldo |  |
| 7927 | 81.1 | **Call control and roaming to support IMS in UMTS** | 1806d | 2000-01-03 A | 2006-12-01 A | 100% | 2000-01-03 | 2006-12-01 | 1806d |  |  | S2; R5 | 109760h | 109760h | Rel-5 | Maurice |  | IMS-CCR |  | IMS-CCR | Lucent | Liz Daniel |  |
| 7928 | 81.1.1 | Stage 1 for Call control and roaming to support IMS in UMTS | 215d | 2000-02-21 A | 2000-12-15 A | 100% | 2000-02-21 | 2000-12-15 | 215d | finish no earlier than 2000-09-21 |  | S1 | 1720h | 1720h | Rel-5 | Alain |  |  | 22.228 |  | Motorola | Mark Cataldo |  |
| 7929 | 81.1.2 | Stage 2 (Architecture and Main flows) | 246d | 2000-04-14 A | 2001-03-23 A | 100% | 2000-04-14 | 2001-03-23 | 246d | finish no earlier than 2001-03-23 |  | S2 | 1968h | 1968h | Rel-5 | Maurice |  |  | 23.228 |  | Lucent | Liz Daniel |  |
| 7930 | 81.1.3 | Impact on MM/CC/SM | 400d | 2000-08-28 A | 2002-03-08 A | 100% | 2000-08-28 | 2002-03-08 | 400d | finish no earlier than 2002-03-08 |  | N1 | 3200h | 3200h | Rel-5 | Frederic |  | IMS-CCR-IWMM |  | IMS-CCR-IWMM | Lucent | Keith Drage (drage@alcatel-lucent.com) |  |
| 7931 | 81.1.4 | **SIP Call Control protocol for the IMS** | 385d | 2000-10-02 A | 2002-03-22 A | 100% | 2000-10-02 | 2002-03-22 | 385d |  |  | N1 | 12320h | 12320h | Rel-5 | Frederic |  |  | 24.228; 24.229; 23.218 |  | Lucent | Keith Drage (drage@alcatel-lucent.com) |  |
| 7932 | 81.1.4.1 | IMS signalling flows | 385d | 2000-10-02 A | 2002-03-22 A | 100% | 2000-10-02 | 2002-03-22 | 385d | finish no earlier than 2002-03-22 |  | N1 | 3080h | 3080h | Rel-5 | Frederic |  |  | 24.228 |  |  |  |  |
| 7933 | 81.1.4.2 | IMS stage 3 | 385d | 2000-10-02 A | 2002-03-22 A | 100% | 2000-10-02 | 2002-03-22 | 385d | finish no earlier than 2002-03-22 |  | N1 | 3080h | 3080h | Rel-5 | Frederic |  |  | 24.229 |  |  |  |  |
| 7934 | 81.1.4.3 | IMS Session Handling; stage 2 | 385d | 2000-10-02 A | 2002-03-22 A | 100% | 2000-10-02 | 2002-03-22 | 385d | finish no earlier than 2002-03-22 |  | N1 | 3080h | 3080h | Rel-5 | Frederic |  |  | 23.218 |  |  |  |  |
| 7935 | 16.5.1 | Conformance Test Aspects – IMS Call Control | 451d | 2005-03-11 A | 2006-12-01 A | 100% | 2005-03-11 | 2006-12-01 | 451d |  | 2006-06-02 | R5 | 3608h | 3608h | Rel-5 | Ingbert |  | IMS-CCR_Test | 34.108; 34.229-1; 34.229-2; 34.229-3 | IMS-CCR_Test | Motorola | Jacob.John@motorola.com | Fri 11/03/05 |
| 7936 | 81.1.4.4 | **Main IETF dependencies** | 641d | 2000-01-03 A | 2002-06-14 A | 100% | 2000-01-03 | 2002-06-14 | 641d |  |  | NP | 58048h | 58048h | Rel-5 | Kimmo |  |  |  |  | Lucent |  |  |
| 7937 | 81.1.4.4.1 | IETF: RFC 3261 (Session Initiation Protocol) | 346d | 2000-11-24 A | 2002-03-22 A | 100% | 2000-11-24 | 2002-03-22 | 346d | finish no earlier than 2002-03-22 |  | N1 | 2768h | 2768h | Rel-5 | Frederic |  |  |  |  | Lucent |  |  |
| 7938 | 81.1.4.4.2 | IETF: RFC 3262 (Reliability of provisional responses) | 346d | 2000-11-24 A | 2002-03-22 A | 100% | 2000-11-24 | 2002-03-22 | 346d | finish no earlier than 2002-03-22 |  | N1 | 2768h | 2768h | Rel-5 | Frederic |  |  |  |  | Lucent |  |  |
| 7939 | 81.1.4.4.3 | IETF: RFC 3312 (Without COMET)(Integration of resource management and SIP) | 382d | 2000-11-24 A | 2002-05-13 A | 100% | 2000-11-24 | 2002-05-13 | 382d | finish no earlier than 2002-05-13 |  | N1 | 3056h | 3056h | Rel-5 | Frederic |  |  |  |  | Lucent |  |  |
| 7940 | 81.1.4.4.4 | IETF: RFC 3323 (SIP extensions for caller identity and privacy) | 382d | 2000-11-24 A | 2002-05-13 A | 100% | 2000-11-24 | 2002-05-13 | 382d | finish no earlier than 2002-05-13 |  | N1 | 3056h | 3056h | Rel-5 | Frederic |  |  |  |  | Lucent |  |  |
| 7941 | 81.1.4.4.5 | IETF: RFC 3313 (SIP extensions for media authorization) | 382d | 2000-11-24 A | 2002-05-13 A | 100% | 2000-11-24 | 2002-05-13 | 382d | finish no earlier than 2002-05-13 |  | N1 | 3056h | 3056h | Rel-5 | Frederic |  |  |  |  | Lucent |  |  |
| 7942 | 81.1.4.4.6 | IETF: RFC 3265 (specific event notification) | 346d | 2000-11-24 A | 2002-03-22 A | 100% | 2000-11-24 | 2002-03-22 | 346d | finish no earlier than 2002-03-22 |  | N1 | 2768h | 2768h | Rel-5 | Frederic |  |  |  |  | Lucent |  |  |
| 7943 | 81.1.4.4.7 | IETF: RFC editor Queue (refer method) | 401d | 2000-11-24 A | 2002-06-07 A | 100% | 2000-11-24 | 2002-06-07 | 401d | finish no earlier than 2002-06-07 |  | N1 | 3208h | 3208h | Rel-5 | Frederic |  |  |  |  | Lucent |  |  |
| 7944 | 81.1.4.4.8 | IETF: RFC editor Queue (DHCP options for SIP servers) | 382d | 2000-11-24 A | 2002-05-13 A | 100% | 2000-11-24 | 2002-05-13 | 382d | finish no earlier than 2002-05-13 |  | N1 | 3056h | 3056h | Rel-5 | Frederic |  |  |  |  | Lucent |  |  |
| 7945 | 81.1.4.4.10 | IETF: RFC 3267 (AMR and AMR WB RTP and SDP) | 346d | 2000-11-24 A | 2002-03-22 A | 100% | 2000-11-24 | 2002-03-22 | 346d | finish no earlier than 2002-03-22 |  | N1 | 2768h | 2768h | Rel-5 | Frederic |  |  |  |  | Lucent |  |  |
| 7946 | 81.1.4.4.11 | IETF: RFC 3266 (IPv6 support within SDP) | 581d | 2000-01-03 A | 2002-03-22 A | 100% | 2000-01-03 | 2002-03-22 | 581d | finish no earlier than 2002-03-22 |  | N1 | 4640h | 4640h | Rel-5 | Frederic |  |  |  |  | Lucent |  |  |
| 7947 | 81.1.4.4.12 | IETF: RFC 3311 (The Update method) | 382d | 2000-11-24 A | 2002-05-13 A | 100% | 2000-11-24 | 2002-05-13 | 382d | finish no earlier than 2002-05-13 |  | N1 | 3056h | 3056h | Rel-5 | Frederic |  |  |  |  | Lucent |  |  |
| 7948 | 81.1.4.4.13 | IETF: RFC 3324 (Network Asserted Identity) | 382d | 2000-11-24 A | 2002-05-13 A | 100% | 2000-11-24 | 2002-05-13 | 382d | finish no earlier than 2002-05-13 |  | N1 | 3056h | 3056h | Rel-5 | Frederic |  |  |  |  | Lucent |  |  |
| 7949 | 81.1.4.4.14 | IETF: RFC editor Queue (Various 3GPP Private Extensions) | 382d | 2000-11-24 A | 2002-05-13 A | 100% | 2000-11-24 | 2002-05-13 | 382d | finish no earlier than 2002-05-13 |  | N1 | 3056h | 3056h | Rel-5 | Frederic |  |  |  |  | Lucent |  |  |

Notes:
- 7922: Marked as stopped 12/2008
- 7923: Marked as stopped 12/2008
- 7924: Marked as stopped 12/2008
- 7925: Formerly 'Shared Network support in connected mode', renamed at RAN #16.
- 7926: -
- 7927: -
- 7928: Issues include e.g.: Roaming requirements, Requirements on supplementary services, Interworking requirements
- 7929: Issues include e.g.: Mobile IP, RAB selection principles, Optimized VoIP bearer mechanisms, SIP multimedia protocol
- 7930: Per 26/2-02: This is understood to be the PCO & TFT CRs which CN1 provides to TSGN #15 for approval. If this is correct understanding, then the task is 100 % complete.
- 7931: TSGN_10 approved the change:CN1 - SA2 SIP joint meeting spotted one more place for improvement: work tasks with ID 1998 and 1278 are actually subtasks under of single CN1 WT. One WI has been approved for the CN1 WT with title "SIP Call Control protocol
- 7932: 24.228
- 7933: 24.229
- 7934: 23.218
- 7935: -
- 7936: -
- 7937: -
- 7938: -
- 7939: -
- 7940: -
- 7941: -
- 7942: -
- 7943: -
- 7944: -
- 7945: -
- 7946: -
- 7947: -
- 7948: -
- 7949: -

| ID | WBS | Task | Duration | Start | Finish | Complete | Baseline start | Baseline finish | Baseline duration | Constraint | Resources | Work | Actual work | Release | MCC resp | Acronym | Impacted TSs and TRs | WI rapporteur name | WI rapporteur e-mail | Acronym_3GU_Export | TSG stopped |
| --- | --- | --- | --- | --- | --- | --- | --- | --- | --- | --- | --- | --- | --- | --- | --- | --- | --- | --- | --- | --- | --- |
| 7950 | 81.1.4.5 | **Addressing** | 380d | 2000-10-09 A | 2002-03-22 A | 100% | 2000-10-09 | 2002-03-22 | 380d |  | S2 | 7744h | 7744h | Rel-5 | Maurice |  |  |  |  |  |  |
| 7951 | 81.1.4.5.1 | Architectural issues | 235d | 2000-10-09 A | 2001-08-31 A | 100% | 2000-10-09 | 2001-08-31 | 235d | finish no earlier than 2001-03-16 | S2 | 1880h | 1880h | Rel-5 | Maurice |  |  |  |  |  |  |
| 7952 | 81.1.4.5.2 | Impact on HSS | 353d | 2000-11-15 A | 2002-03-22 A | 100% | 2000-11-15 | 2002-03-22 | 353d | finish no earlier than 2002-03-22 | N4 | 2824h | 2824h | Rel-5 | Kimmo |  |  |  |  |  |  |
| 7953 | 81.1.4.6 | **Service Examples (Work stopped)** | 304d | 2001-04-17 A | 2002-06-14 A | 100% | 2001-04-17 | 2002-06-14 | 304d |  | S1 | 4864h | 4864h | Rel-5 | Alain | IMS-Sex | 22.928 | Motorola | Mark Cataldo | IMS-Sex |  |
| 7954 | 81.1.4.6.1 | IMS Framework Report (work stopped) | 304d | 2001-04-17 A | 2002-06-14 A | 100% | 2001-04-17 | 2002-06-14 | 304d | finish no earlier than 2002-06-14 | S1 | 2432h | 2432h | Rel-5 | Alain | IMS-FrWk | 22.941 | SBC | Randolph Wohlert (rwohlert@tri.sbc.com) | IMS-FrWk |  |
| 7955 | 81.2 | **Access Security for IMS** | 190d | 2001-10-08 A | 2002-06-28 A | 100% | 2001-10-08 | 2002-06-28 | 190d |  | S3; T3 | 5640h | 5640h | Rel-5 | Mirko | IMS-ASEC |  | Ericsson | krister.boman@emw.ericsson.se | IMS-ASEC |  |
| 7956 | 81.2.2 | IMS impacts on UICC (ISIM application) | 185d | 2001-10-08 A | 2002-06-21 A | 100% | 2001-10-08 | 2002-06-21 | 185d | finish no earlier than 2002-06-21 | T3 | 1480h | 1480h | Rel-5 | Xavier |  | 33.102; New 31.103 | Vodafone | Jeremy Norris |  |  |
| 7957 | 81.2.3 | Deleted - SIP extensions for Integrity protection | 140d | 2001-12-17 A | 2002-06-28 A | 100% | 2001-12-17 | 2002-06-28 | 140d | finish no earlier than 2002-06-28 | N1 | 1120h | 1120h | Rel-5 | Frederic |  |  |  |  |  | SP-69 |
| 7958 | 81.3 | Security Aspects of Requirement for Network Configuration Independence | 130d | 2001-07-02 A | 2001-12-28 A | 100% | 2001-07-02 | 2001-12-28 | 130d | finish no earlier than 2001-12-28 | S3 | 1040h | 1040h | Rel-5 | Mirko | SEC1-NCI | 33.203 | AT&T Wireless | hugh.shieh@attws.com | SEC1-NCI |  |
| 7959 | 81.4 | IMS Lawful Interception | 410d | 2000-09-04 A | 2002-03-29 A | 100% | 2000-09-04 | 2002-03-29 | 410d | finish no earlier than 2002-03-29 | S3 | 3280h | 3280h | Rel-5 | Mirko | IMS-LI | 33.106; 33.107; New 33.108 | Reg TP | berthold.wilhelm@regtp.de | IMS-LI |  |
| 7960 | 81.5 | Charging and OAM&P for IMS | 383d | 2000-12-25 A | 2002-06-12 A | 100% | 2000-12-25 | 2002-06-12 | 383d | finish no earlier than 2002-06-12 | S5 | 3064h | 3064h | Rel-5 | Mirko | IMS-OAM | 32-series |  |  | IMS-OAM |  |
| 7961 | 81.6 | **Multimedia codecs and protocols for conversational PS services** | 568d | 2000-07-26 A | 2002-09-27 A | 100% | 2000-07-26 | 2002-09-27 | 568d |  | S4 | 15640h | 15640h | Rel-5 | Paolo | IMS-CODEC | 26.235; 26.236 | Toshiba, Nokia | B. Aronson (Toshiba), pasi.s.ojala@nokia.com | IMS-CODEC |  |
| 7962 | 81.6.1 | Codecs | 427d | 2000-07-26 A | 2002-03-14 A | 100% | 2000-07-26 | 2002-03-14 | 427d | finish no earlier than 2001-03-21 | S4 | 3416h | 3416h | Rel-5 | Paolo |  | 26.235; 26.236 |  |  |  |  |
| 7963 | 81.6.2 | Transport protocols | 1d | 2002-03-12 A | 2002-03-12 A | 100% | 2002-03-12 | 2002-03-12 | 1d | finish no earlier than 2002-03-12 | S4 | 8h | 8h | Rel-5 | Paolo |  | 26.236 | Nokia | P. Ojala |  |  |
| 7964 | 81.6.4 | recommendation for QoS parameter values for various media types | 195d | 2001-12-31 A | 2002-09-27 A | 100% | 2001-12-31 | 2002-09-27 | 195d | finish no earlier than 2002-09-27 | S4 | 1560h | 1560h | Rel-5 | Paolo |  |  |  |  |  |  |
| 7965 | 81.6.5 | IETF: RFC 3310 (HTTP Digest Authentication using AKA) | 382d | 2000-11-24 A | 2002-05-13 A | 100% | 2000-11-24 | 2002-05-13 | 382d | finish no earlier than 2002-05-13 | N1 | 3056h | 3056h | Rel-5 | Frederic |  |  |  |  |  |  |
| 7966 | 81.6.6 | IETF: RFC 3329 (Security mechanism agreement for SIP connections) | 382d | 2000-11-24 A | 2002-05-13 A | 100% | 2000-11-24 | 2002-05-13 | 382d | finish no earlier than 2002-05-13 | N1 | 3056h | 3056h | Rel-5 | Frederic |  |  |  |  |  |  |
| 7967 | 81.7 | **SIP message compression** | 185d | 2001-09-24 A | 2002-06-07 A | 100% | 2001-09-24 | 2002-06-07 | 185d |  | S2 | 3128h | 3128h | Rel-5 | Maurice |  |  |  |  |  |  |
| 7968 | 81.7.1 | Stage 2 for SIP message compression | 25d | 2001-09-24 A | 2001-10-26 A | 100% | 2001-09-24 | 2001-10-26 | 25d | finish no earlier than 2001-10-26 | S2 | 200h | 200h | Rel-5 | Maurice |  |  |  |  |  |  |
| 7969 | 81.7.2 | Compression signalling | 181d | 2001-09-28 A | 2002-06-07 A | 100% | 2001-09-28 | 2002-06-07 | 181d | finish no earlier than 2002-06-07 | N1 | 1448h | 1448h | Rel-5 | Frederic |  |  |  |  |  |  |
| 7970 | 81.8 | **Stage 3 description of IMS interfaces** | 383d | 2001-03-14 A | 2002-08-30 A | 100% | 2001-03-14 | 2002-08-30 | 383d |  | NP | 29531.6h | 29531.6h | Rel-5 | Kimmo |  |  |  |  |  |  |
| 7971 | 81.8.1 | Cx interface (HSS to CSCF) | 135.95d | 2001-03-14 A | 2002-06-07 A | 100% | 2001-03-14 | 2002-06-07 | 135.95d | finish no earlier than 2002-06-07 | N4 | 1087.58h | 1087.58h | Rel-5 | Kimmo |  |  |  |  |  |  |
| 7972 | 81.8.2 | Mp interface (MRFC - MRFP) enhancements | 258d | 2001-03-14 A | 2002-03-08 A | 100% | 2001-03-14 | 2002-03-08 | 258d | finish no earlier than 2002-06-07 | N4 | 2064h | 2064h | Rel-5 | Kimmo |  |  |  |  |  |  |
| 7973 | 81.8.3 | Mw interface (CSCF to P-CSCF) | 323d | 2001-03-14 A | 2002-06-07 A | 100% | 2001-03-14 | 2002-06-07 | 323d | finish no earlier than 2002-06-07 | N1 | 2584h | 2584h | Rel-5 | Frederic |  |  |  |  |  |  |
| 7974 | 81.8.4 | Mr interface (CSCF to MRF) | 273d | 2001-03-14 A | 2002-03-29 A | 100% | 2001-03-14 | 2002-03-29 | 273d | finish no earlier than 2002-03-29 | N1 | 2184h | 2184h | Rel-5 | Frederic |  |  |  |  |  |  |
| 7975 | 81.8.5 | Dx interface (I-CSCF to SLF) | 323d | 2001-03-14 A | 2002-06-07 A | 100% | 2001-03-14 | 2002-06-07 | 323d | finish no earlier than 2002-06-07 | N4 | 2584h | 2584h | Rel-5 | Kimmo |  |  |  |  |  |  |
| 7976 | 81.8.6 | Go interface (GGSN to PCF) | 323d | 2001-03-14 A | 2002-06-07 A | 100% | 2001-03-14 | 2002-06-07 | 323d | finish no earlier than 2002-06-07 | N3 | 2584h | 2584h | Rel-5 | Gwiho |  |  |  |  |  |  |
| 7977 | 81.8.7 | ISC (IMS Service Control) Interface | 323d | 2001-03-14 A | 2002-06-07 A | 100% | 2001-03-14 | 2002-06-07 | 323d | finish no earlier than 2002-06-07 | N1 | 2584h | 2584h | Rel-5 | Frederic |  |  |  |  |  |  |
| 7978 | 81.8.8 | Sh interface (HSS to AS) | 82d | 2002-02-14 A | 2002-06-07 A | 100% | 2002-02-14 | 2002-06-07 | 82d | finish no earlier than 2002-06-07 | N4 | 656h | 656h | Rel-5 | Kimmo |  |  |  |  |  |  |
| 7979 | 81.8.9 | Si interface (HSS to IM-SSF) | 162.5d | 2002-01-16 A | 2002-08-30 A | 100% | 2002-01-16 | 2002-08-30 | 162.5d | finish no earlier than 2002-06-07 | N4 | 1300h | 1300h | Rel-5 | Kimmo |  |  |  |  |  |  |
| 7980 | 81.8.10 | Gm interface (UE to CSCF) | 323d | 2001-03-14 A | 2002-06-07 A | 100% | 2001-03-14 | 2002-06-07 | 323d | finish no earlier than 2002-06-07 | N1 | 2584h | 2584h | Rel-5 | Frederic |  |  |  |  |  |  |
| 7981 | 81.8.11 | Mi interface (CSCF to BGCF) | 323d | 2001-03-14 A | 2002-06-07 A | 100% | 2001-03-14 | 2002-06-07 | 323d | finish no earlier than 2002-06-07 | N1 | 2584h | 2584h | Rel-5 | Frederic |  |  |  |  |  |  |
| 7982 | 81.8.12 | Mj interface (BGCF to MGCF) | 323d | 2001-03-14 A | 2002-06-07 A | 100% | 2001-03-14 | 2002-06-07 | 323d | finish no earlier than 2002-06-07 | N1 | 2584h | 2584h | Rel-5 | Frederic |  |  |  |  |  |  |
| 7983 | 81.8.13 | Mk interface (BGCF to BGCF) | 323d | 2001-03-14 A | 2002-06-07 A | 100% | 2001-03-14 | 2002-06-07 | 323d | finish no earlier than 2002-06-07 | N1 | 2584h | 2584h | Rel-5 | Frederic |  |  |  |  |  |  |
| 7984 | 81.9 | Support of VHE/OSA by entities and protocols of the IMS (e.g. CSCF) | 186d | 2001-09-21 A | 2002-06-07 A | 100% | 2001-09-21 | 2002-06-07 | 186d | finish no earlier than 2002-06-07 | N5 | 1488h | 1488h | Rel-5 | Kimmo | IMS-ONOSA | 29.198; 29.998 | Ericsson | Ard.Jan.Moerdijk@eln.ericsson.se | IMS-ONOSA |  |

Notes:
- 7950: -
- 7951: -
- 7952: Covered by 29.228 & 29228
- 7953: -
- 7954: -
- 7955: -
- 7956: -
- 7957: CN1 is not aware of any requirements and is not doing anything on this task
- 7958: Consider security aspects in SA2 TS 23.228 clause 4.4 & annex C
- 7959: SP#17 completed
- 7960: -
- 7961: -
- 7962: -
- 7963: -
- 7964: -
- 7965: -
- 7966: -
- 7967: -
- 7968: -
- 7969: -
- 7970: -
- 7971: -
- 7972: [DAB 08-03-02] - No work required in CN4
- 7973: -
- 7974: -
- 7975: CN4#11 30/11/01: No inputs received in CN4
- 7976: [DAB - 23/05/03] - 100 % complete
- 7977: -
- 7978: CN4#11 30/11/01: No inputs received in CN4
- 7979: SA16: Part of Rel5 only if completed in September 02. Marked as closed 12/2008 (was marked 72% complete)
- 7980: -
- 7981: -
- 7982: -
- 7983: -
- 7984: -

| ID | WBS | Task | Duration | Start | Finish | Predecessors | Complete | Baseline start | Baseline finish | Baseline duration | Constraint | Resources | Work | Actual work | Acronym | WI rapporteur name | WI rapporteur e-mail | Release | MCC resp | Acronym_3GU_Export | TSG stopped | Impacted TSs and TRs | PCG approved | TSG approved |
| --- | --- | --- | --- | --- | --- | --- | --- | --- | --- | --- | --- | --- | --- | --- | --- | --- | --- | --- | --- | --- | --- | --- | --- | --- |
| 7985 | 81.10 | **CAMEL control of IMS services** | 365d | 2001-04-16 A | 2002-09-06 A |  | 100% | 2001-04-16 | 2002-09-06 | 365d |  | N2 | 9952h | 9952h | IMS-CAMEL | Lucent | Angelica Remoquillo | Rel-5 | Kimmo | IMS-CAMEL |  |  |  |  |
| 7986 | 81.10.1 | Stage2 work 'general' | 365d | 2001-04-16 A | 2002-09-06 A |  | 100% | 2001-04-16 | 2002-09-06 | 365d | finish no earlier than 2002-09-06 | N2 | 2920h | 2920h |  |  |  | Rel-5 | Kimmo |  |  |  |  |  |
| 7987 | 81.10.2 | Stage3 work 'CAP' | 175d | 2002-01-07 A | 2002-09-06 A |  | 100% | 2002-01-07 | 2002-09-06 | 175d | finish no earlier than 2002-09-06 | N2 | 1400h | 1400h |  |  |  | Rel-5 | Kimmo |  |  |  |  |  |
| 7988 | 81.10.3 | Stage2 work 'Si interface' | 175d | 2002-01-07 A | 2002-09-06 A |  | 100% | 2002-01-07 | 2002-09-06 | 175d | finish no earlier than 2002-09-06 | N2 | 1400h | 1400h |  |  |  | Rel-5 | Kimmo |  |  |  |  |  |
| 7989 | 81.10.4 | Stage3 work 'Si interface' | 82d | 2002-02-14 A | 2002-06-07 A |  | 100% | 2002-02-14 | 2002-06-07 | 82d | finish no earlier than 2002-06-07 | N4 | 656h | 656h |  |  |  | Rel-5 | Kimmo |  |  |  |  |  |
| 7990 | 81.10.5 | Deleted - SDM issues for CAMEL control of IMS | 82d | 2002-02-14 A | 2002-06-07 A |  | 100% | 2002-02-14 | 2002-06-07 | 82d | finish no earlier than 2002-06-07 | N4 | 656h | 656h |  |  |  | Rel-5 | Kimmo |  | NP-17 |  |  |  |
| 7991 | 81.11 | Pre-pay/real-time charging in IMS | 196d | 2001-06-15 A | 2002-03-15 A |  | 100% | 2001-06-15 | 2002-03-15 | 196d | finish no earlier than 2002-03-15 | S1 | 1568h | 1568h |  |  |  | Rel-5 | Alain |  |  |  |  |  |
| 7992 | 81.12 | **IMS Charging** | 289d | 2001-08-06 A | 2002-09-12 A |  | 100% | 2001-08-06 | 2002-09-12 | 289d |  | S2; S5 | 8944h | 8944h | OAM-CH | T-Mobile | karl-heinz.nenner@t-mobile.de | Rel-5 | Mirko | OAM-CH |  | 32.225 |  |  |
| 7993 | 81.12.1 | Charging Implications of IMS architecture | 75d | 2001-08-06 A | 2001-11-16 A |  | 100% | 2001-08-06 | 2001-11-16 | 75d | finish no earlier than 2001-11-16 | S2 | 600h | 600h |  |  |  | Rel-5 | Maurice |  |  |  |  |  |
| 7994 | 81.12.2 | Charging management for IMS (off-line & on-line) | 214d | 2001-11-19 A | 2002-09-12 A | 7993 | 100% | 2001-11-19 | 2002-09-12 | 214d | finish no earlier than 2002-09-12 | S5 | 1712h | 1712h |  |  |  | Rel-5 | Mirko |  |  | 32.225 |  |  |
| 7995 | 86.1.6.10 | Billing, accounting and call detail record aspects | 251d | 2001-09-27 A | 2002-09-12 A |  | 100% | 2001-09-27 | 2002-09-12 | 251d | finish no earlier than 2002-09-12 | S5 | 2008h | 2008h |  | T-Mobile | Karl-Heinz.Nenner@T-MOBILE.DE | Rel-5 | Mirko |  |  | 32.225 |  |  |
| 7996 | 81.13 | **Other IETF dependencies** | 401d | 2000-11-24 A | 2002-06-07 A |  | 100% | 2000-11-24 | 2002-06-07 | 401d |  | NP | 9624h | 9624h |  |  |  | Rel-5 |  |  |  |  |  |  |
| 7997 | 81.13.1 | IETF: draft-ietf-aaa-diameter - should be CN4 | 401d | 2000-11-24 A | 2002-06-07 A |  | 100% | 2000-11-24 | 2002-06-07 | 401d | finish no earlier than 2002-06-07 | NP | 3208h | 3208h |  |  |  | Rel-5 |  |  |  |  |  |  |
| 7998 | 81.13.2 | IETF: draft-johansson-aaa-diameter-mm-app - should be CN4 | 401d | 2000-11-24 A | 2002-06-07 A |  | 100% | 2000-11-24 | 2002-06-07 | 401d | finish no earlier than 2002-06-07 | NP | 3208h | 3208h |  |  |  | Rel-5 |  |  |  |  |  |  |
| 7999 | 81.15 | Conformance Test Aspects - Provisioning of IMS | 205d | 2002-03-18 A | 2002-12-27 A |  | 100% | 2002-03-18 | 2002-12-27 | 205d | finish no earlier than 2002-12-27 | T1 | 1640h | 1640h | IMS-TEST |  |  | Rel-5 | Ingbert | IMS-TEST |  |  |  |  |
| 8000 | 81.16 | Testing of support for IMS - prose | 270d | 2002-09-18 A | 2003-09-30 A |  | 100% | 2002-09-18 | 2003-09-30 | 270d | finish no earlier than 2003-09-30 | T1 | 2160h | 2160h |  | Anritsu | dan.fox@eu.anritsu.com | Rel-5 | Ingbert |  |  | 34.108; 34.123 |  |  |
| 8001 | 81.17 | Testing of support for IMS - TTCN | 381d | 2002-09-18 A | 2004-03-03 A |  | 100% | 2002-09-18 | 2004-03-03 | 381d | finish no earlier than 2004-03-03 | T1 | 3048h | 3048h |  | Anritsu | dan.fox@eu.anritsu.com | Rel-5 | Ingbert |  |  | 34.108; 34.123 |  |  |
| 8002 | 2459 | UE Conformance Test Aspects – IMS for Converged IP Communications | 263d? | 2016-12-14 A | 2017-12-15 A |  | 100% |  |  |  | finish no earlier than 2017-12-15 | R5 | 2104h | 2104h | IMS_CONV_IP_COM-UEConTest | Rohnert, Hans | Hans.Rohnert.ext@rohde-schwarz.com | Rel-5 |  |  |  | 34.229-1; 34.229-2; 34.229-3 | 38 | 74 |
| 8003 | 82 | **Extended Transparent End-to-End PS Streaming Service** | 313d? | 2002-01-03 A | 2003-03-17 A |  | 100% | 2002-01-03 | 2003-03-17 | 313d? |  | S4 | 6224h | 6224h | PSS-E | Ericsson | olle.franceschi@ericsson.com | Rel-5 | Paolo | PSS-E |  | 26.233; 26.234 |  |  |
| 8004 | 82.1 | **Stage 1 for Extended Transparent End-to-End PS Streaming Service** | 86d? | 2002-11-18 A | 2003-03-17 A |  | 100% | 2002-11-18 | 2003-03-17 | 86d? |  | S1 | 1376h | 1376h |  | Vodafone | stephen.wolak@vodafone.com | Rel-5 | Alain |  |  | 22.233 |  |  |
| 8005 | 2460.1.1 | Interaction with other services | 86d? | 2002-11-18 A | 2003-03-17 A |  | 100% | 2002-11-18 | 2003-03-17 | 86d? | finish no earlier than 2003-03-17 | S1 | 688h | 688h |  | Vodafone | stephen.wolak@vodafone.com | Rel-5 | Alain |  |  | 22.233 |  |  |
| 8006 | 82.2 | Stage 2 (version Rel-5 of TS 26.234) | 51d | 2002-01-03 A | 2002-03-14 A |  | 100% | 2002-01-03 | 2002-03-14 | 51d | finish no earlier than 2002-03-26 | S4 | 408h | 408h |  |  |  | Rel-5 | Paolo |  |  | 26.234 |  |  |
| 8007 | 82.3 | RTP usage model | 242d | 2002-01-03 A | 2002-12-06 A |  | 100% | 2002-01-03 | 2002-12-06 | 242d | finish no earlier than 2002-12-06 | S4 | 1936h | 1936h |  |  |  | Rel-5 | Paolo |  |  | 26.937 |  |  |
| 8008 | 83 | **Rel-5 Open Service Access (OSA) enhancements** | 955d | 1999-04-27 A | 2002-12-20 A |  | 100% | 1999-04-27 | 2002-12-20 | 955d |  | S1; S3 | 72648h | 72648h | OSA1 | Siemens | joerg.swetina@neclab.eu | Rel-5 | Alain | OSA1 |  | 22.127; 23.127; 29.198-x; 29.998-x |  |  |
| 8009 | 83.1 | General Stage 2 for Rel-5 | 194d | 2001-09-11 A | 2002-06-07 A |  | 100% | 2001-09-11 | 2002-06-07 | 194d |  | S2 | 1232h | 1232h |  |  |  | Rel-5 | Maurice |  |  |  |  |  |

Notes:
- 7985: -
- 7986: DAB 12.12.01 split into cn4 and cn2 parts
- 7987: DAB 12.12.01 split into cn4 and cn2 parts
- 7988: DAB 12.12.01 split into cn4 and cn2 parts
- 7989: [DAB 08-03-02] - UID 12004 is MASTER of UID 14998
- 7990: Marked as stopped 12/2008
- 7991: Marked as closed 12/2008 (was marked 60% complete)
- 7992: -
- 7993: -
- 7994: -
- 7995: -
- 7996: Was introduced at SP#13 by Ileana Leuca (exact position in the WP and related WG have to be defined)
- 7997: Marked as closed 12/2008 (was marked 90% complete)
- 7998: Marked as closed 12/2008 (was marked 50% complete)
- 7999: The task is a BB, individual work items were considered but are constrained by lack of supporting companies. Marked as stopped 12/2008
- 8000: Marked as stopped 12/2008
- 8001: Marked as stopped 12/2008
- 8002: UID: 740999->740068¦Rel-14->Rel-519/9/17: Compl:0%->75%¦ 8/1/18: Compl:75%->100%
- 8003: -
- 8004: 2nd resp SA4
- 8005: 2nd resp SA4. Marked as closed 12/2008 (was marked 65% complete)
- 8006: 2nd resp SA2
- 8007: Marked as closed 12/2008 (was marked 90% complete)
- 8008: -
- 8009: Marked as closed 12/2008 (was marked 47% complete)

| ID | WBS | Task | Duration | Start | Finish | Predecessors | Complete | Baseline start | Baseline finish | Baseline duration | Constraint | Resources | Work | Actual work | Acronym | Release | MCC resp | Acronym_3GU_Export | Impacted TSs and TRs | WI rapporteur name | WI rapporteur e-mail |
| --- | --- | --- | --- | --- | --- | --- | --- | --- | --- | --- | --- | --- | --- | --- | --- | --- | --- | --- | --- | --- | --- |
| 8010 | 83.2 | **OSA APIs for Multimedia Call Control** | 499d | 2000-07-11 A | 2002-06-07 A |  | 100% | 2000-07-11 | 2002-06-07 | 499d |  | S2 | 5960h | 5960h | OSA1-CSCF | Rel-5 | Maurice | OSA1-CSCF |  |  |  |
| 8011 | 83.2.1 | Stage 1 for OSA APIs for Multimedia Call Control | 438d | 2000-07-11 A | 2002-03-14 A |  | 100% | 2000-07-11 | 2002-03-14 | 438d | finish no earlier than 2002-03-14 | S1 | 3504h | 3504h |  | Rel-5 | Alain |  | 22.127 | Siemens | Manfred.leitgeb@siemens.at |
| 8012 | 83.2.2 | Stages 2 and 3 for Multimedia Call Control | 194d | 2001-09-11 A | 2002-06-07 A |  | 100% | 2001-09-11 | 2002-06-07 | 194d | finish no earlier than 2002-06-07 | N5 | 1552h | 1552h |  | Rel-5 | Kimmo |  | 29.198-04 |  |  |
| 8013 | 83.3 | Generic user interaction - Stage 3 | 194d | 2001-09-11 A | 2002-06-07 A |  | 100% | 2001-09-11 | 2002-06-07 | 194d | finish no earlier than 2002-06-07 | N5 | 1552h | 1552h |  | Rel-5 | Kimmo |  | 29.198-05 |  |  |
| 8014 | 83.4 | OSA Charging - Stage 3 | 194d | 2001-09-11 A | 2002-06-07 A |  | 100% | 2001-09-11 | 2002-06-07 | 194d | finish no earlier than 2002-06-07 | N5 | 1552h | 1552h |  | Rel-5 | Kimmo |  | 29.198-12 |  |  |
| 8015 | 83.5 | Call Control Service Mapping; Multiparty Call Control SIP - Stage 3 | 194d | 2001-09-11 A | 2002-06-07 A |  | 100% | 2001-09-11 | 2002-06-07 | 194d | finish no earlier than 2002-06-07 | N5 | 1552h | 1552h |  | Rel-5 | Kimmo |  | 29.998-04-4 |  |  |
| 8016 | 83.6 | WSDL APIs for SOAP/HTTP - Stage 3 | 455d | 2000-09-11 A | 2002-06-07 A |  | 100% | 2000-09-11 | 2002-06-07 | 455d | finish no earlier than 2002-06-07 | N5 | 3640h | 3640h |  | Rel-5 | Kimmo |  | 29.198; 29.998 |  |  |
| 8017 | 83.7 | **OSA Security** | 639d | 2000-07-11 A | 2002-12-20 A |  | 100% | 2000-07-11 | 2002-12-20 | 639d |  | S3 | 15000h | 15000h | OSA1-SEC | Rel-5 | Mirko | OSA1-SEC | 33.102 | Ericsson | colin.blanchard@bt.com |
| 8018 | 83.7.1 | Stage 1 for OSA Security | 349d | 2000-07-11 A | 2001-11-09 A |  | 100% | 2000-07-11 | 2001-11-09 | 349d | finish no earlier than 2001-11-09 | S1 | 2792h | 2792h |  | Rel-5 | Alain |  | 22.127 | Siemens | Manfred.leitgeb@siemens.at |
| 8019 | 83.7.2 | OSA Stage 3 | 430d | 2000-10-23 A | 2002-06-14 A |  | 100% | 2000-10-23 | 2002-06-14 | 430d | finish no earlier than 2002-06-14 | S3 | 3440h | 3440h |  | Rel-5 | Mirko |  | 33.102 | BT, Ericsson | colin.blanchard@bt.com |
| 8020 | 83.7.3 | security related SCF(s) definition | 186d | 2001-09-21 A | 2002-06-07 A |  | 100% | 2001-09-21 | 2002-06-07 | 186d | finish no earlier than 2002-06-07 | N5 | 1488h | 1488h |  | Rel-5 | Kimmo |  | 29.198; 29.998 | Ericsson | Ard.Jan.Moerdijk@eln.ericsson.se |
| 8021 | 83.7.4 | OSA changes required from supporting platforms, e.g. gsmSCF, HLR | 69d | 2000-09-11 A | 2000-12-14 A |  | 100% | 2000-09-11 | 2000-12-14 | 69d | finish no earlier than 2000-12-14 | S3 | 552h | 552h |  | Rel-5 | Mirko |  | 33.102 | BT, Ericsson | colin.blanchard@bt.com |
| 8022 | 2461.7.5 | OSA Security (moved from Rel-6) | 202d | 2002-03-14 A | 2002-12-20 A |  | 100% | 2002-03-14 | 2002-12-20 | 202d | finish no earlier than 2002-12-20 | S3 | 1616h | 1616h |  | Rel-5 | Mirko |  | 33.102 | BT, Ericsson | colin.blanchard@bt.com |
| 8023 | 83.8 | **Interactions OSA - e-commerce** | 815d | 1999-04-27 A | 2002-06-07 A |  | 100% | 1999-04-27 | 2002-06-07 | 815d |  | S2 | 6152h | 6152h | OSA1-ECOM | Rel-5 | Maurice | OSA1-ECOM |  |  |  |
| 8024 | 83.8.1 | Stage 1 for Interactions OSA - e-commerce | 439d | 1999-04-27 A | 2000-12-28 A |  | 100% | 1999-04-27 | 2000-12-28 | 439d | finish no earlier than 2000-12-28 | S1 | 3504h | 3504h |  | Rel-5 | Alain |  | 22.127 | Siemens | joerg.swetina@neclab.eu |
| 8025 | 83.8.2 | Stages 2 and 3 for Interactions OSA - e-commerce | 186d | 2001-09-21 A | 2002-06-07 A |  | 100% | 2001-09-21 | 2002-06-07 | 186d | finish no earlier than 2002-06-07 | N5 | 1488h | 1488h |  | Rel-5 | Kimmo |  | 29.198; 29.998 | Ericsson | Ard.Jan.Moerdijk@eln.ericsson.se |
| 8026 | 83.9 | Policy Management - Stage 3 | 194d | 2001-09-11 A | 2002-06-07 A |  | 100% | 2001-09-11 | 2002-06-07 | 194d | finish no earlier than 2002-06-07 | N5 | 1552h | 1552h |  | Rel-5 | Kimmo |  | 29.198-13 |  |  |
| 8027 | 83.10 | Presence and Availability Management (PAM) - Stage 3 | 194d | 2001-09-11 A | 2002-06-07 A |  | 100% | 2001-09-11 | 2002-06-07 | 194d | finish no earlier than 2002-06-07 | N5 | 1552h | 1552h |  | Rel-5 | Kimmo |  | 29.198-14 |  |  |
| 8028 | 83.11 | **LCS - OSA interfaces** | 455d | 2000-09-11 A | 2002-06-07 A |  | 100% | 2000-09-11 | 2002-06-07 | 455d |  | S1 | 5656h | 5656h | OSA1-LCSI | Rel-5 | Alain | OSA1-LCSI |  | Siemens | joerg.swetina@neclab.eu |
| 8029 | 83.11.1 | Stage 1 for LCS - OSA interfaces | 65d | 2000-09-11 A | 2000-12-08 A |  | 100% | 2000-09-11 | 2000-12-08 | 65d | finish no earlier than 2000-12-08 | S1 | 520h | 520h |  | Rel-5 | Alain |  | 22.127 | Siemens | joerg.swetina@neclab.eu |
| 8030 | 83.11.2 | Stage 2 for LCS - OSA interfaces | 1d | 2000-12-11 A | 2000-12-11 A | 8029 | 100% | 2000-12-11 | 2000-12-11 | 1d | finish no earlier than 2000-12-11 | S2 | 8h | 8h |  | Rel-5 | Maurice |  | 23.127 | Ericsson | Christophe GOURRAUD |
| 8031 | 83.11.3 | Stage 3 for LCS - OSA interfaces | 186d | 2001-09-21 A | 2002-06-07 A | 8030 | 100% | 2001-09-21 | 2002-06-07 | 186d | finish no earlier than 2002-06-07 | N5 | 1488h | 1488h |  | Rel-5 | Kimmo |  | 29.198; 29.998 | Ericsson | Ard.Jan.Moerdijk@eln.ericsson.se |
| 8032 | 2461.12 | Access to User Profile | 145d | 2001-06-01 A | 2001-12-20 A |  | 100% | 2001-06-01 | 2001-12-20 | 145d | finish no earlier than 2001-12-20 | S1 | 1160h | 1160h | OSA2-UP | Rel-5 | Alain | OSA2-UP |  |  |  |
| 8033 | 2461.13 | **Retrieval of Terminal capabilities** | 634d | 2000-07-11 A | 2002-12-13 A |  | 100% | 2000-07-11 | 2002-12-13 | 634d |  | S2 | 10808h | 10808h | OSA2-TC | Rel-5 | Maurice | OSA2-TC |  |  |  |
| 8034 | 2461.13.1 | Stage 1 for Retrieval of Terminal capabilities | 132d | 2000-07-11 A | 2001-01-10 A |  | 100% | 2000-07-11 | 2001-01-10 | 132d | finish no earlier than 2001-01-10 | S1 | 1056h | 1056h |  | Rel-5 | Alain |  | 22.127 | Siemens | joerg.swetina@neclab.eu |
| 8035 | 2461.13.2 | Stages 2 and 3 for Retrieval of Terminal capabilities | 321d | 2001-09-21 A | 2002-12-13 A | 8034 | 100% | 2001-09-21 | 2002-12-13 | 321d | finish no earlier than 2002-12-13 | N5 | 2568h | 2568h |  | Rel-5 | Kimmo |  | 29.198; 29.998 | Ericsson | Ard.Jan.Moerdijk@eln.ericsson.se |
| 8036 | 2461.13.3 | Provisioning of the terminal capabilities | 445d | 2001-04-02 A | 2002-12-13 A |  | 100% | 2001-04-02 | 2002-12-13 | 445d | finish no earlier than 2002-12-13 | T2 | 3560h | 3560h |  | Rel-5 |  |  | 23.057 |  |  |

Notes:
- 8010: For Rel5 even if completed by March
- 8011: -
- 8012: -
- 8013: -
- 8014: -
- 8015: -
- 8016: -
- 8017: SP#8 approved WID
- 8018: -
- 8019: SP#8 approved WID
- 8020: -
- 8021: SP#8 approved WID
- 8022: SP#8 approved WID
- 8023: -
- 8024: Marked as closed 12/2008 (was marked 95% complete)
- 8025: -
- 8026: -
- 8027: -
- 8028: az: CN#13 - changed to Rel5
- 8029: -
- 8030: az 24/05/01: Rel4 completion 90->100%.
- 8031: -
- 8032: -
- 8033: -
- 8034: -
- 8035: -
- 8036: According to T2 SWG1 M. Cataldo this is automatically supported by the MExE support of UAProf therefore 100% complete

| ID | WBS | Task | Duration | Start | Finish | Predecessors | Complete | Baseline start | Baseline finish | Baseline duration | Constraint | Resources | Work | Actual work | Acronym | WI rapporteur name | WI rapporteur e-mail | Release | MCC resp | Acronym_3GU_Export | Impacted TSs and TRs |
| --- | --- | --- | --- | --- | --- | --- | --- | --- | --- | --- | --- | --- | --- | --- | --- | --- | --- | --- | --- | --- | --- |
| 8037 | 84 | **CAMEL phase 4** | 625d | 2000-04-17 A | 2002-09-06 A |  | 100% | 2000-04-17 | 2002-09-06 | 625d |  | S1 | 41104h | 41104h | CAMEL4 | Nokia | keijo.palviainen@nokia.com | Rel-5 | Alain | CAMEL4 |  |
| 8038 | 84.1 | Service requirements | 565d | 2000-04-17 A | 2002-06-14 A |  | 100% | 2000-04-17 | 2002-06-14 | 565d | finish no earlier than 2002-06-14 | S1 | 4520h | 4520h |  |  |  | Rel-5 | Alain |  |  |
| 8039 | 84.2 | Call Party Handling | 500d | 2000-07-10 A | 2002-06-07 A |  | 100% | 2000-07-10 | 2002-06-07 | 500d | finish no earlier than 2002-06-07 | N2 | 4000h | 4000h | CAMEL4-CPH |  |  | Rel-5 | Kimmo | CAMEL4-CPH |  |
| 8040 | 84.3 | Mid call procedure for MO and MT calls | 495d | 2000-07-17 A | 2002-06-07 A |  | 100% | 2000-07-17 | 2002-06-07 | 495d | finish no earlier than 2002-06-07 | N2 | 3960h | 3960h | CAMEL4-MCP |  |  | Rel-5 | Kimmo | CAMEL4-MCP |  |
| 8041 | 84.4 | Interactions with Optimal Routing | 430d | 2000-07-17 A | 2002-03-08 A |  | 100% | 2000-07-17 | 2002-03-08 | 430d | finish no earlier than 2002-03-08 | N2 | 3440h | 3440h | CAMEL4-IOR |  |  | Rel-5 | Kimmo | CAMEL4-IOR |  |
| 8042 | 84.5 | Inclusion of flexible tone injection | 430d | 2000-07-17 A | 2002-03-08 A |  | 100% | 2000-07-17 | 2002-03-08 | 430d | finish no earlier than 2002-03-08 | N2 | 3440h | 3440h | CAMEL4-IFTI |  |  | Rel-5 | Kimmo | CAMEL4-IFTI |  |
| 8043 | 84.6 | CSE control over MT SMS | 430d | 2000-07-17 A | 2002-03-08 A |  | 100% | 2000-07-17 | 2002-03-08 | 430d | finish no earlier than 2002-03-08 | N2 | 3440h | 3440h | CAMEL4-CCSMS |  |  | Rel-5 | Kimmo | CAMEL4-CCSMS |  |
| 8044 | 84.7 | Notification of GPRS mobility management to CSE | 331d | 2001-03-02 A | 2002-06-07 A |  | 100% | 2001-03-02 | 2002-06-07 | 331d | finish no earlier than 2002-06-07 | N2 | 2648h | 2648h | CAMEL4-NMM |  |  | Rel-5 | Kimmo | CAMEL4-NMM |  |
| 8045 | 84.8 | Provision of location information of called subscriber | 266d | 2001-03-02 A | 2002-03-08 A |  | 100% | 2001-03-02 | 2002-03-08 | 266d | finish no earlier than 2002-03-08 | N2 | 2128h | 2128h | CAMEL4-LOCB |  |  | Rel-5 | Kimmo | CAMEL4-LOCB |  |
| 8046 | 84.9 | Inclusion of ODB data in the CSE_HLR interface | 175d | 2001-07-09 A | 2002-03-08 A |  | 100% | 2001-07-09 | 2002-03-08 | 175d | finish no earlier than 2002-03-08 | N2 | 1400h | 1400h | CAMEL4-ODB |  |  | Rel-5 | Kimmo | CAMEL4-ODB |  |
| 8047 | 84.10 | Location information during an ongoing call (Handover DP) | 280d | 2001-05-14 A | 2002-06-07 A |  | 100% | 2001-05-14 | 2002-06-07 | 280d | finish no earlier than 2002-06-07 | N2 | 2240h | 2240h | CAMEL4-HODP |  |  | Rel-5 | Kimmo | CAMEL4-HODP |  |
| 8048 | 84.11 | GPRS Any Time Interrogation | 240d | 2001-07-09 A | 2002-06-07 A |  | 100% | 2001-07-09 | 2002-06-07 | 240d | finish no earlier than 2002-06-07 | N2 | 1920h | 1920h | CAMEL4-ATI |  |  | Rel-5 | Kimmo | CAMEL4-ATI |  |
| 8049 | 84.12 | Transfer of IMEI (with SW version) to CSE (CAMEL4-ATI) | 240d | 2001-07-09 A | 2002-06-07 A |  | 100% | 2001-07-09 | 2002-06-07 | 240d | finish no earlier than 2002-06-07 | N2 | 1920h | 1920h |  |  |  | Rel-5 | Kimmo |  |  |
| 8050 | 84.13 | Handling of partial implementations of CAMEL4 | 131d | 2002-03-08 A | 2002-09-06 A |  | 100% | 2002-03-08 | 2002-09-06 | 131d | finish no earlier than 2002-06-07 | N2 | 1048h | 1048h | CAMEL4-SUB |  |  | Rel-5 | Kimmo | CAMEL4-SUB |  |
| 8051 | 85 | **Rel-5 MExE enhancements** | 250d | 2001-03-26 A | 2002-03-08 A |  | 100% | 2001-03-26 | 2002-03-08 | 250d |  | T2 | 2880h | 2880h | MEXE5 |  |  | Rel-5 | Kimmo | MEXE5 |  |
| 8052 | 85.1 | MExE Rel-5 Improvements and Investigations | 110d | 2001-03-26 A | 2002-03-08 A |  | 100% | 2001-03-26 | 2002-03-08 | 110d | finish no earlier than 2001-12-17 | T2 | 880h | 880h | MEXE5-ENHANC | Motorola | Mark Cataldo | Rel-5 | Kimmo | MEXE5-ENHANC | 22.057; 23.057 |
| 8053 | 86 | **Wideband Telephony Service - AMR** | 1036d | 2000-01-01 A | 2003-12-19 A |  | 100% | 2000-01-01 | 2003-12-19 | 1036d |  | S4 | 75408h | 75408h | AMRWB | Siemens | Imre.Varga@mch.siemens.de | Rel-5 | Paolo | AMRWB |  |
| 8054 | 86.1 | **Specification** | 636d | 2000-01-01 A | 2002-06-07 A |  | 100% | 2000-01-01 | 2002-06-07 | 636d |  | S4 | 19984h | 19984h |  |  |  | Rel-5 | Paolo |  |  |
| 8055 | 86.1.1 | Stage 1 for Wideband Telephony Service - AMR | 125d | 2001-10-01 A | 2002-03-22 A |  | 100% | 2001-10-01 | 2002-03-22 | 125d | finish no earlier than 2002-03-22 | S1 | 1000h | 1000h |  |  |  | Rel-5 | Alain |  |  |
| 8056 | 86.1.2 | **Stage 2 for Wideband Telephony Service - AMR** | 77d | 2000-01-03 A | 2000-04-17 A |  | 100% | 2000-01-03 | 2000-04-17 | 77d |  | S4 | 1232h | 1232h |  |  |  | Rel-5 | Paolo |  |  |
| 8057 | 86.1.2.1 | Design Constraints for Wideband Telephony Service - AMR | 27d | 2000-01-03 A | 2000-02-07 A |  | 100% | 2000-01-03 | 2000-02-07 | 27d |  | S4 | 208h | 208h |  |  |  | Rel-5 | Paolo |  |  |
| 8058 | 86.1.2.2 | General Description for Wideband Telephony Service - AMR | 51d | 2000-02-07 A | 2000-04-17 A | 8057 | 100% | 2000-02-07 | 2000-04-17 | 51d | start no earlier than 2000-09-25 | S4 | 408h | 408h |  |  |  | Rel-5 | Paolo |  |  |
| 8059 | 86.1.3 | Feasibility Study for Wideband Telephony Service - AMR | 26d | 2000-04-28 A | 2000-06-02 A | 8058 | 100% | 2000-04-28 | 2000-06-02 | 26d | finish no earlier than 2000-06-02 | S4 | 208h | 208h |  |  |  | Rel-5 | Paolo |  | 26.901 |
| 8060 | 86.1.4 | N1 Aspects for Wideband Telephony Service - AMR | 66d | 2001-09-21 A | 2001-12-21 A |  | 100% | 2001-09-21 | 2001-12-21 | 66d | finish no earlier than 2001-12-21 | N1 | 528h | 528h |  |  |  | Rel-5 | Frederic |  |  |
| 8061 | 86.1.5 | N4 work for Wideband Telephony Service - AMR | 83d | 2002-02-13 A | 2002-06-07 A |  | 100% | 2002-02-13 | 2002-06-07 | 83d | finish no earlier than 2002-06-07 | N4 | 664h | 664h |  |  |  | Rel-5 | Kimmo |  |  |

Notes:
- 8037: -
- 8038: -
- 8039: -
- 8040: -
- 8041: -
- 8042: -
- 8043: -
- 8044: -
- 8045: -
- 8046: Added on May 29, 2001
- 8047: -
- 8048: -
- 8049: -
- 8050: stage2 and stage3 CRs for approval at CN#17
- 8051: -
- 8052: -
- 8053: -
- 8054: -
- 8055: -
- 8056: -
- 8057: -
- 8058: -
- 8059: S4,TD SP-000024: TR 26.901 v.4.0.0
- 8060: Some of N1 tasks: Indication of supported codecs by the MS, Bearer cap negociation, codec indication to MS
- 8061: CN4#11 30/11/01: No inputs to CN4 at this meeting

| ID | WBS | Task | Duration | Start | Finish | Predecessors | Complete | Baseline start | Baseline finish | Baseline duration | Constraint | Resources | Work | Actual work | Release | MCC resp | Acronym | Acronym_3GU_Export | Impacted TSs and TRs | TSG stopped | WI rapporteur name | WI rapporteur e-mail |
| --- | --- | --- | --- | --- | --- | --- | --- | --- | --- | --- | --- | --- | --- | --- | --- | --- | --- | --- | --- | --- | --- | --- |
| 8062 | 86.1.6 | **Codec issues** | 636d | 2000-01-03 A | 2002-06-07 A |  | 100% | 2000-01-03 | 2002-06-07 | 636d |  | S4 | 9496h | 9496h | Rel-5 | Paolo |  |  |  |  |  |  |
| 8063 | 86.1.6.1 | Codec qualification | 86d | 2000-02-02 A | 2000-05-31 A |  | 100% | 2000-02-02 | 2000-05-31 | 86d | finish no earlier than 2000-05-31 | S4 | 688h | 688h | Rel-5 | Paolo |  |  |  |  |  |  |
| 8064 | 86.1.6.2 | Codec selection tests | 102d | 2000-06-01 A | 2000-10-20 A | 8063 | 100% | 2000-06-01 | 2000-10-20 | 102d | finish no earlier than 2000-10-20 | S4 | 816h | 816h | Rel-5 | Paolo |  |  |  |  |  |  |
| 8065 | 86.1.6.3 | Codec selection | 5d | 2000-10-23 A | 2000-10-27 A | 8064 | 100% | 2000-10-23 | 2000-10-27 | 5d | finish no earlier than 2000-10-27 | S4 | 40h | 40h | Rel-5 | Paolo |  |  |  |  |  |  |
| 8066 | 86.1.6.4 | TFO AMR-WB | 63d | 2001-12-18 A | 2002-03-14 A |  | 100% | 2001-12-18 | 2002-03-14 | 63d | finish no earlier than 2002-03-14 | S4 | 504h | 504h | Rel-5 | Paolo | AMRWB-TFO | AMRWB-TFO |  |  |  |  |
| 8067 | 86.1.6.5 | Other codec issues (verif., characterization) | 441d | 2000-09-29 A | 2002-06-07 A |  | 100% | 2000-09-29 | 2002-06-07 | 441d | finish no earlier than 2002-06-07 | S4 | 3528h | 3528h | Rel-5 | Paolo |  |  | 26.976 |  |  |  |
| 8068 | 86.1.6.6 | AMR-WB and narrrowband interworking | 121d | 2001-09-27 A | 2002-03-14 A |  | 100% | 2001-09-27 | 2002-03-14 | 121d | finish no earlier than 2002-03-14 | S4 | 968h | 968h | Rel-5 | Paolo | AMRWB-IWG | AMRWB-IWG |  |  |  |  |
| 8069 | 86.1.6.7 | Interworking with fixed broadband networks | 121d | 2001-09-27 A | 2002-03-14 A |  | 100% | 2001-09-27 | 2002-03-14 | 121d | finish no earlier than 2002-03-14 | S4 | 968h | 968h | Rel-5 | Paolo |  |  |  |  |  |  |
| 8070 | 86.1.6.8 | Tones and announcements | 121d | 2001-09-27 A | 2002-03-14 A |  | 100% | 2001-09-27 | 2002-03-14 | 121d | finish no earlier than 2002-03-14 | S4 | 968h | 968h | Rel-5 | Paolo |  |  |  |  |  |  |
| 8071 | 86.1.6.9 | Deleted - WB Conferencing and WB Voice Group calls | 1d | 2000-01-03 A | 2000-01-03 A |  | 100% | 2000-01-03 | 2000-01-03 | 1d | finish no earlier than 2000-01-03 | S1 | 8h | 8h | Rel-5 | Alain |  |  |  | SP-07 |  |  |
| 8072 | 86.1.8 | **Conformance tests (CRs to 34 series)** | 74d | 2000-01-01 A | 2000-04-12 A |  | 100% | 2000-01-01 | 2000-04-12 | 74d |  | T1 | 1768h | 1768h | Rel-5 | Ingbert |  |  |  |  |  |  |
| 8073 | 86.1.8.1 | **Terminal Acoustic Characteristics** | 74d | 2000-01-01 A | 2000-04-12 A |  | 100% | 2000-01-01 | 2000-04-12 | 74d |  | S4 | 1176h | 1176h | Rel-5 | Paolo |  |  |  |  |  |  |
| 8074 | 86.1.8.1.1 | Definition for Terminal Acoustic Characteristics | 22d | 2000-01-01 A | 2000-01-31 A |  | 100% | 2000-01-01 | 2000-01-31 | 22d | finish no earlier than 2000-01-28 | S4 | 168h | 168h | Rel-5 | Paolo |  |  | 26.131 |  |  |  |
| 8075 | 86.1.8.1.2 | Test specification for Terminal Acoustic Characteristics | 52d | 2000-02-01 A | 2000-04-12 A | 8074 | 100% | 2000-02-01 | 2000-04-12 | 52d | finish no earlier than 2000-03-13 | S4 | 416h | 416h | Rel-5 | Paolo |  |  | 26.132 |  |  |  |
| 8076 | 86.2 | Floating-point ANSI-C code for the AMR-WB speech codec | 123d | 2001-09-25 A | 2002-03-14 A |  | 100% | 2001-09-25 | 2002-03-14 | 123d | finish no earlier than 2002-03-14 | S4 | 984h | 984h | Rel-5 | Paolo | AMRWB-FP | AMRWB-FP | 26.204 |  | Nokia | janne.m.vainio@nokia.com |
| 8077 | 86.3 | **Support of AMR-WB in GERAN: GMSK and 8PSK WB FR / HR** | 651d | 2000-01-03 A | 2002-06-28 A |  | 100% | 2000-01-03 | 2002-06-28 | 651d |  | GP | 23488h | 23488h | Rel-5 | Paolo | GAMRWB | GAMRWB |  |  |  |  |
| 8078 | 86.3.1 | Channel coding in 45.003 for Support of AMR-WB in GERAN: GMSK and 8PSK WB FR / HR | 591d | 2000-01-03 A | 2002-04-05 A |  | 100% | 2000-01-03 | 2002-04-05 | 591d |  | GP | 4720h | 4720h | Rel-5 | Paolo |  |  |  |  |  |  |
| 8079 | 86.3.2 | Signalling for the A interface | 391d | 2000-01-03 A | 2001-06-29 A |  | 100% | 2000-01-03 | 2001-06-29 | 391d | finish no earlier than 2001-06-29 | GP | 3120h | 3120h | Rel-5 | Paolo |  |  |  |  |  |  |
| 8080 | 86.3.3 | Signalling for Iu | 651d | 2000-01-03 A | 2002-06-28 A |  | 100% | 2000-01-03 | 2002-06-28 | 651d | finish no earlier than 2002-06-28 | GP | 5200h | 5200h | Rel-5 | Paolo |  |  |  |  |  |  |
| 8081 | 86.3.4 | Receiver performance in TS 45.005 | 325d | 2001-04-02 A | 2002-06-28 A |  | 100% | 2001-04-02 | 2002-06-28 | 325d | finish no earlier than 2002-06-28 | GP | 2600h | 2600h | Rel-5 | Paolo |  |  |  |  |  |  |
| 8082 | 86.3.5 | Link Adaptation in 45.009 | 330d | 2001-03-26 A | 2002-06-28 A |  | 100% | 2001-03-26 | 2002-06-28 | 330d | finish no earlier than 2002-06-28 | GP | 2640h | 2640h | Rel-5 | Paolo |  |  |  |  |  |  |
| 8083 | 86.4 | **Deleted - GERAN MS conformance test for AMR-WB** | 1036d | 2000-01-03 A | 2003-12-19 A |  | 100% | 2000-01-03 | 2003-12-19 | 1036d |  | GP | 16568h | 16568h | Rel-5 | Paolo |  |  |  | SP-69 |  |  |
| 8084 | 86.4.1 | Deleted - MS test for AMR-WB | 1036d | 2000-01-03 A | 2003-12-19 A |  | 100% | 2000-01-03 | 2003-12-19 | 1036d | finish no earlier than 2003-12-19 | GP | 8280h | 8280h | Rel-5 | Paolo |  |  |  | GP-17 |  |  |
| 8085 | 86.5 | GERAN BTS conformance test for AMR-WB | 762d | 2000-01-03 A | 2002-12-02 A |  | 100% | 2000-01-03 | 2002-12-02 | 762d |  | GP | 6096h | 6096h | Rel-5 | Paolo |  |  |  |  |  |  |

Notes:
- 8062: -
- 8063: -
- 8064: -
- 8065: -
- 8066: -
- 8067: ANSI C-Code , Test Sequences, Speech Transcoding Functions, Error Concealment of lost frames, Source Controlled Bit-Rate Operation, Voice Activity Detector, Frame Structure
- 8068: -
- 8069: -
- 8070: -
- 8071: -
- 8072: -
- 8073: -
- 8074: -
- 8075: -
- 8076: -
- 8077: -
- 8078: 50098 -> 50298
- 8079: -
- 8080: -
- 8081: -
- 8082: -
- 8083: Not started 02/2003. Marked as stopped 12/2008
- 8084: Marked as stopped 12/2008
- 8085: -

| ID | WBS | Task | Duration | Start | Finish | Complete | Baseline start | Baseline finish | Baseline duration | Constraint | Resources | Work | Actual work | Acronym | Release | MCC resp | Acronym_3GU_Export | WI rapporteur name | WI rapporteur e-mail |
| --- | --- | --- | --- | --- | --- | --- | --- | --- | --- | --- | --- | --- | --- | --- | --- | --- | --- | --- | --- |
| 8086 | 11 | **Rel-5 Terminal interfaces** | 223d | 2001-05-14 A | 2002-03-20 A | 100% | 2001-05-14 | 2002-03-20 | 223d |  | T2 | 3568h | 3568h | TLM5 | Rel-5 | Kimmo | TI, TLM5 |  |  |
| 8087 | 87 | Terminal local model enhancements | 223d | 2001-05-14 A | 2002-03-20 A | 100% | 2001-05-14 | 2002-03-20 | 223d | finish no earlier than 2002-03-20 | T2 | 1784h | 1784h | TLM5 | Rel-5 |  | TLM5 |  |  |
| 8088 | 88 | **Rel-5 Location Services enhancements** | 845d | 2000-04-03 A | 2003-06-27 A | 100% | 2000-04-03 | 2003-06-27 | 845d |  | S2; S1; S3; S5; N4; R2; R3; GP | 237560h | 237560h | LCS1 | Rel-5 | Maurice | LCS1, Rel-5 | Nokia | Jan Kall |
| 8089 | 88.1 | **UE positioning for Rel-5 Location Services enhancements** | 315d | 2001-01-15 A | 2002-03-29 A | 100% | 2001-01-15 | 2002-03-29 | 315d |  | R2 | 6120h | 6120h | LCS1-Uepos | Rel-5 | Issam | LCS1-Uepos, Rel-5 |  |  |
| 8090 | 88.1.1 | UE positioning enhancements for 1.28 Mcps TDD | 255d | 2001-04-09 A | 2002-03-29 A | 100% | 2001-04-09 | 2002-03-29 | 255d | finish no earlier than 2002-03-29 | R2 | 2040h | 2040h | LCS-128Pos | Rel-5 | Yong-Jun | LCS-128Pos | CATT | Xiaohua Mei |
| 8091 | 88.1.2 | Open SMLC-SRNC Interface within the UTRAN to support A-GPS Positioning | 195d | 2001-01-15 A | 2001-10-12 A | 100% | 2001-01-15 | 2001-10-12 | 195d |  | R2 | 1560h | 1560h | LCS-INTF | Rel-5 | Yong-Jun | LCS-INTF | Qualcomm | Kirk Burroughs |
| 8092 | 88.2 | **Event Based and Periodic LCS** | 535d | 2000-05-22 A | 2002-06-07 A | 100% | 2000-05-22 | 2002-06-07 | 535d |  | S1; S2; N4 | 14848h | 14848h | LCS1-EBP | Rel-5 | Alain | LCS1-EBP | Pacific Bell Wireless | Randolph Wohlert (rwohlert@tri.sbc.com) |
| 8093 | 88.2.1 | Stage 1 for Event based and Periodic LCS | 130d | 2000-05-22 A | 2000-11-17 A | 100% | 2000-05-22 | 2000-11-17 | 130d | finish no earlier than 2000-07-21 | S1 | 1040h | 1040h |  | Rel-5 | Alain |  | Pacific Bell Wireless | Randolph Wohlert (rwohlert@tri.sbc.com) |
| 8094 | 88.2.2 | Stage 2 for Event based and Periodic LCS | 60d | 2000-11-06 A | 2001-01-26 A | 100% | 2000-11-06 | 2001-01-26 | 60d | finish no earlier than 2001-01-26 | S2 | 480h | 480h |  | Rel-5 | Maurice |  |  |  |
| 8095 | 88.2.3 | Impact on MAP | 61d | 2002-03-15 A | 2002-06-07 A | 100% | 2002-03-15 | 2002-06-07 | 61d | finish no earlier than 2002-06-07 | N4 | 488h | 488h |  | Rel-5 | Kimmo |  |  |  |
| 8096 | 88.3 | **Location Services for GERAN in A/Gb Mode** | 485d | 2000-04-03 A | 2002-02-08 A | 100% | 2000-04-03 | 2002-02-08 | 485d |  | GP | 26400h | 26400h | LCS-GERAN | Rel-5 | Paolo | LCS-GERAN | Nokia | Margaret Livingston |
| 8097 | 88.3.1 | GERAN LCS Stage 2 (first release) | 485d | 2000-04-03 A | 2002-02-08 A | 100% | 2000-04-03 | 2002-02-08 | 485d | finish no earlier than 2002-02-08 | GP; S2; G1; G2 | 15520h | 15520h |  | Rel-5 | Paolo |  | Nokia | Margaret Livingston |
| 8098 | 88.3.2 | Gb interface support for LCS | 370d | 2000-04-03 A | 2001-08-31 A | 100% | 2000-04-03 | 2001-08-31 | 370d | finish no earlier than 2001-08-31 | GP | 2960h | 2960h |  | Rel-5 | Paolo |  | Nokia | Margaret Livingston |
| 8099 | 88.3.3 | L3 protocol support for LCS | 305d | 2000-04-03 A | 2001-06-01 A | 100% | 2000-04-03 | 2001-06-01 | 305d | finish no earlier than 2001-06-01 | GP | 2440h | 2440h |  | Rel-5 | Paolo |  | Nokia | Margaret Livingston |
| 8100 | 88.3.4 | Stage 3 for Location Services for GERAN in A/Gb Mode | 305d | 2000-04-03 A | 2001-06-01 A | 100% | 2000-04-03 | 2001-06-01 | 305d | finish no earlier than 2001-06-01 | GP | 2440h | 2440h |  | Rel-5 | Paolo |  | Nokia | Margaret Livingston |
| 8101 | 88.4 | **Location Services for GERAN in Iu Mode** | 585d | 2000-04-03 A | 2002-06-28 A | 100% | 2000-04-03 | 2002-06-28 | 585d |  | S2; G1; G2; R2; R3 | 64264h | 64264h |  | Rel-5 | Paolo |  | Nokia | Margaret Livingston |
| 8102 | 88.4.1 | GERAN LCS Stage 2 | 585d | 2000-04-03 A | 2002-06-28 A | 100% | 2000-04-03 | 2002-06-28 | 585d | finish no earlier than 2002-06-28 | S2; G1; G2 | 14040h | 14040h |  | Rel-5 | Paolo |  | Nokia | Margaret Livingston |
| 8103 | 88.4.2 | Iu-ps interface support for LCS | 585d | 2000-04-03 A | 2002-06-28 A | 100% | 2000-04-03 | 2002-06-28 | 585d | finish no earlier than 2002-06-28 | R2; R3 | 9360h | 9360h |  | Rel-5 | Paolo |  | Nokia | Margaret Livingston |
| 8104 | 88.4.3 | Iu-cs interface support for LCS | 585d | 2000-04-03 A | 2002-06-28 A | 100% | 2000-04-03 | 2002-06-28 | 585d | finish no earlier than 2002-06-28 | R2; R3 | 9360h | 9360h |  | Rel-5 | Paolo |  | Nokia | Margaret Livingston |
| 8105 | 88.4.4 | Iur-g interface support for LCS | 62.5d | 2002-01-23 A | 2002-04-19 A | 100% | 2002-01-23 | 2002-04-19 | 62.5d | finish no earlier than 2002-04-19 | G1; G2 | 1000h | 1000h |  | Rel-5 | Paolo |  | Nokia | Margaret Livingston |
| 8106 | 88.4.5 | RRC protocol support for LCS | 75d | 2001-08-20 A | 2001-11-30 A | 100% | 2001-08-20 | 2001-11-30 | 75d | finish no earlier than 2001-11-30 | G1; G2; R2; R3 | 2400h | 2400h |  | Rel-5 | Paolo |  | Nokia | Margaret Livingston |
| 8107 | 88.4.6 | Additional impacts on Broadcast of LCS data on packet channels | 77.5d | 2001-08-20 A | 2001-12-05 A | 100% | 2001-08-20 | 2001-12-05 | 77.5d | finish no earlier than 2001-12-05 | G1; G2; R2; R3 | 2480h | 2480h |  | Rel-5 | Paolo |  | Nokia | Margaret Livingston |
| 8108 | 88.4.7 | Stage 3 for Location Services for GERAN in Iu Mode | 69.5d | 2002-03-25 A | 2002-06-28 A | 100% | 2002-03-25 | 2002-06-28 | 69.5d | finish no earlier than 2002-06-28 | G1; G2; R2; R3 | 2224h | 2224h |  | Rel-5 | Paolo |  | Nokia | Margaret Livingston |
| 8109 | 88.5 | **GERAN MS Conformance test for LCS** | 280d | 2002-06-03 A | 2003-06-27 A | 100% | 2002-06-03 | 2003-06-27 | 280d |  | GP | 11200h | 11200h | LCS-GERAN-MSconf | Rel-5 | Paolo | LCS-GERAN-MSconf |  |  |
| 8110 | 88.5.1 | LCS MS test case work plan (Release 98/99/4) | 280d | 2002-06-03 A | 2003-06-27 A | 100% | 2002-06-03 | 2003-06-27 | 280d | finish no earlier than 2003-06-27 | G4; G5 | 4480h | 4480h |  | Rel-5 | Paolo |  |  |  |
| 8111 | 88.5.2 | LCS MS test cases | 280d | 2002-06-03 A | 2003-06-27 A | 100% | 2002-06-03 | 2003-06-27 | 280d | finish no earlier than 2003-06-27 | G4; G5 | 4480h | 4480h |  | Rel-5 | Paolo |  |  |  |

Notes:
- 8086: Acronym changed from "TI, TLMN5"
- 8087: - / Impacted TSs and TRs: 23.227
- 8088: . Acronym changed from "LCS1, Rel-5"
- 8089: Acronym changed from "LCS1-Uepos, Rel-5"
- 8090: - / Impacted TSs and TRs: 25.123; 25.224; 25.225; 25.302; 25.303; 25.304; 25.305; 25.331; 25.420; 25.423; 25.430; 25.433; New 25.859
- 8091: RP#13 completed
- 8092: -
- 8093: Evaluate Event based and Periodic LCS to be included in R00, corresponding Stage 1 description / Impacted TSs and TRs: 22.071
- 8094: Marked as closed 12/2008 (was marked 51% complete)
- 8095: Possible impact on UTRAN of LCS quality level request
- 8096: -
- 8097: -
- 8098: -
- 8099: -
- 8100: -
- 8101: -
- 8102: -
- 8103: -
- 8104: -
- 8105: FFS
- 8106: -
- 8107: -
- 8108: -
- 8109: -
- 8110: Marked as closed 12/2008 (was marked 60% complete)
- 8111: Marked as closed 12/2008 (was marked 60% complete)

| ID | WBS | Task | Duration | Start | Finish | Predecessors | Complete | Baseline start | Baseline finish | Baseline duration | Constraint | Resources | Work | Actual work | Acronym | Release | MCC resp | TSG stopped | Acronym_3GU_Export | Impacted TSs and TRs | WI rapporteur name | WI rapporteur e-mail |
| --- | --- | --- | --- | --- | --- | --- | --- | --- | --- | --- | --- | --- | --- | --- | --- | --- | --- | --- | --- | --- | --- | --- |
| 8112 | 88.6 | **Deleted - GERAN BTS Conformance test for LCS** | 280d | 2002-06-03 A | 2003-06-27 A |  | 100% | 2002-06-03 | 2003-06-27 | 280d |  | GP | 11200h | 11200h | LCS-GERAN-BTSconf | Rel-5 | Paolo | GP-15 | LCS-GERAN-BTSconf |  |  |  |
| 8113 | 88.6.1 | Deleted - LCS BTS test case work plan (Release 98/99/4) | 280d | 2002-06-03 A | 2003-06-27 A |  | 100% | 2002-06-03 | 2003-06-27 | 280d | finish no earlier than 2003-06-27 | G4; G5 | 4480h | 4480h |  | Rel-5 | Paolo | GP-15 |  |  |  |  |
| 8114 | 88.6.2 | Deleted - LCS BTS test cases | 280d | 2002-06-03 A | 2003-06-27 A |  | 100% | 2002-06-03 | 2003-06-27 | 280d | finish no earlier than 2003-06-27 | G4; G5 | 4480h | 4480h |  | Rel-5 | Paolo | GP-15 |  |  |  |  |
| 8115 | 88.7 | LCS interoperation stage 2 aspects | 480d | 2000-08-28 A | 2002-06-28 A |  | 100% | 2000-08-28 | 2002-06-28 | 480d |  | S2 | 3840h | 3840h |  | Rel-5 | Maurice |  |  |  |  |  |
| 8116 | 88.8 | **LCS interoperability aspects to GERAN (LCS-GERAN)** | 480d | 2000-08-28 A | 2002-06-28 A |  | 100% | 2000-08-28 | 2002-06-28 | 480d |  | GP; S5 | 34560h | 34560h |  | Rel-5 | Paolo |  |  |  |  |  |
| 8117 | 88.8.1 | Co-ordinated development of GSM LCS Phase 2 and UMTS LCS, S2 and GERAN | 480d | 2000-08-28 A | 2002-06-28 A |  | 100% | 2000-08-28 | 2002-06-28 | 480d | finish no earlier than 2002-06-28 | GP; S2; S5; R2; R3; G2; G1 | 26880h | 26880h |  | Rel-5 | Paolo |  |  |  |  |  |
| 8118 | 88.9 | FS on LCS support in the IMS | 90d | 2001-02-12 A | 2002-01-18 A |  | 100% | 2001-02-12 | 2002-01-18 | 90d | start no earlier than 2001-02-12 | S1 | 720h | 720h |  | Rel-5 | Alain |  |  |  |  |  |
| 8119 | 88.10 | Charging and OAM&P for LCS enhancements | 201d | 2001-09-21 A | 2002-06-28 A |  | 100% | 2001-09-21 | 2002-06-28 | 201d | finish no earlier than 2002-06-28 | S5 | 1608h | 1608h | LCS1-OAM | Rel-5 | Mirko |  | LCS1-OAM | 32.200-series |  |  |
| 8120 | 88.11 | New security aspects of LCS | 446d | 2000-04-14 A | 2001-12-28 A |  | 100% | 2000-04-14 | 2001-12-28 | 446d | finish no earlier than 2001-12-28 | S3; S2 | 7136h | 7136h | LCS1-SEC | Rel-5 | Mirko |  | LCS1-SEC | 23.271; 43.059 | Nokia | valtteri.niemi@nokia.com |
| 8121 | 88.12 | Specification for the Le interface | 45d | 2002-01-14 A | 2002-03-15 A |  | 100% | 2002-01-14 | 2002-03-15 | 45d | start no earlier than 2002-01-14 | S2 | 360h | 360h | LCS1-Le | Rel-5 | Maurice |  | LCS1-Le |  |  |  |
| 8122 | 88.13 | Deleted - CHECK STATUS - Inter-GMLC interface | 153d | 2002-05-30 A | 2002-12-30 A |  | 100% | 2002-05-30 | 2002-12-30 | 153d | finish no earlier than 2002-12-30 | S2 | 1224h | 1224h |  | Rel-5 | Maurice | SP-10 |  |  |  |  |
| 8123 | 89 | **Rel-5 Security enhancements (SEC1)** | 615d | 2000-02-21 A | 2002-06-28 A |  | 100% | 2000-02-21 | 2002-06-28 | 615d |  | S3 | 29974.9h | 29974.9h |  | Rel-5 | Mirko |  |  |  | Vodafone | Peter.Howard@vodafone.com |
| 8124 | 89.1 | **Rel-5 Network Domain Security (SEC1-NDS)** | 615d | 2000-02-21 A | 2002-06-28 A |  | 100% | 2000-02-21 | 2002-06-28 | 615d |  | S3 | 25054.9h | 25054.9h |  | Rel-5 | Mirko |  |  | New 33.200 (exisalso for Rel-4) | Telenor | Geir-myrdahl.koien@telenor.com |
| 8125 | 89.1.3 | Rel-5 IP network layer security (NDS/IP) (SEC1-NDS-IP) | 457d | 2000-06-15 A | 2002-03-15 A |  | 100% | 2000-06-15 | 2002-03-15 | 457d | finish no earlier than 2002-03-15 | S3 | 3656h | 3656h |  | Rel-5 | Mirko |  |  | New 33.210 | Telenor | Geir-myrdahl.koien@telenor.com |
| 8126 | 89.1.1 | **Deleted - Control plane protection in core network (e.g., GTP, CAP, MAP/IP, provided by IPsec)** | 541d | 2000-05-12 A | 2002-06-07 A |  | 100% | 2000-05-12 | 2002-06-07 | 541d |  | S3 | 7118.9h | 7118.9h |  | Rel-5 | Mirko | SP-16 |  |  |  |  |
| 8127 | 89.1.1.1 | Deleted - Main aspects of User plane protection in core network (e.g., provided by IPsec) | 290d | 2000-05-12 A | 2001-06-21 A |  | 100% | 2000-05-12 | 2001-06-21 | 290d | finish no earlier than 2001-06-21 | S3 | 2320h | 2320h |  | Rel-5 | Mirko | SP-12 |  |  |  |  |
| 8128 | 89.1.1.2 | Deleted - Integration of GTP signalling security architecture - for User plane protection in core network (e.g., provided by IPsec) | 191d | 2001-09-14 A | 2002-06-07 A |  | 100% | 2001-09-14 | 2002-06-07 | 191d | finish no earlier than 2002-06-07 | N4 | 1528h | 1528h |  | Rel-5 | Kimmo | NP-16 |  |  |  |  |
| 8129 | 89.1.2 | **Deleted - User plane protection in core network (e.g., provided by IPsec)** | 615d | 2000-02-21 A | 2002-06-28 A |  | 100% | 2000-02-21 | 2002-06-28 | 615d |  | S3 | 9360h | 9360h |  | Rel-5 | Mirko | SP-16 |  |  |  |  |
| 8130 | 89.1.2.1 | Deleted -Main aspects of User plane protection in core network (e.g., provided by IPsec) | 349d | 2000-02-21 A | 2001-06-21 A |  | 100% | 2000-02-21 | 2001-06-21 | 349d | finish no earlier than 2001-06-21 | S3 | 2792h | 2792h |  | Rel-5 | Mirko | SP-12 |  |  |  |  |
| 8131 | 89.1.2.2 | Deleted - Integration of GTP signalling security architecture - for User plane protection in core network (e.g., provided by IPsec) | 206d | 2001-09-14 A | 2002-06-28 A |  | 100% | 2001-09-14 | 2002-06-28 | 206d | finish no earlier than 2002-06-28 | N4 | 1648h | 1648h |  | Rel-5 | Kimmo | NP-16 |  |  |  |  |
| 8132 | 90 | **Intra Domain Connection of RAN Nodes to Multiple CN Nodes** | 455d | 2000-10-02 A | 2002-06-28 A |  | 100% | 2000-10-02 | 2002-06-28 | 455d |  | S2; N1; N4; R3; GP | 30232h | 30232h | IUFLEX | Rel-5 | Alain |  | IUFLEX | 23.236 | Ericsson | stephen.terrill@ericsson.com |
| 8133 | 90.1 | Overall System Architecture for Intra Domain Connection of RAN Nodes to Multiple CN Nodes | 188d | 2001-01-03 A | 2001-09-21 A |  | 100% | 2001-01-03 | 2001-09-21 | 188d | finish no earlier than 2001-06-01 | S2 | 1504h | 1504h |  | Rel-5 | Maurice |  |  |  |  |  |
| 8134 | 90.2 | Stage 3: RAN node selecting CN node | 130d | 2001-09-24 A | 2002-03-22 A | 8133 | 100% | 2001-09-24 | 2002-03-22 | 130d | finish no earlier than 2002-03-22 | R3 | 1040h | 1040h |  | Rel-5 | Juha |  |  |  | Vodafone | Brendan.McWilliams@gb.vodafone.co.uk |
| 8135 | 90.3 | N1 work for Intra Domain Connection of RAN Nodes to Multiple CN Nodes | 205d | 2001-09-17 A | 2002-06-28 A |  | 100% | 2001-09-17 | 2002-06-28 | 205d | start no earlier than 2001-09-17 | N1 | 1640h | 1640h |  | Rel-5 | Frederic |  |  | 24.008 and check 29.018 |  |  |
| 8136 | 90.4 | N4 work for Intra Domain Connection of RAN Nodes to Multiple CN Nodes | 375d | 2000-10-02 A | 2002-03-08 A |  | 100% | 2000-10-02 | 2002-03-08 | 375d | finish no earlier than 2002-03-15 | N4 | 3000h | 3000h |  | Rel-5 | Kimmo |  |  |  |  |  |

Notes:
- 8112: Not started 02/3003. Marked as stopped 12/2008
- 8113: Marked as stopped 12/2008
- 8114: Marked as stopped 12/2008
- 8115: Marked as closed 12/2008 (was marked 17% complete)
- 8116: -
- 8117: -
- 8118: Marked as closed 12/2008 (was marked 75% complete)
- 8119: -
- 8120: SP#9 updated WID S3-000609 (Location services security)
- 8121: -
- 8122: Marked as stopped 12/2008
- 8123: Added BB UE authentication and rapporteur added. TO BE DELETED
- 8124: SP#9 approved WID SP-000420 (S3-000606 Network domain security). S3#17: All due in Rel5. (WI Update at S3#18). Replaced by NDS-IP and NDS-MAP. TO BE DELETED OR MOVED TO HISTORY FILE
- 8125: SP#12 WID updated SP-000420 (S3-000606) =>SP-010326 (S3-010286)
- 8126: Marked as stopped 12/2008
- 8127: TO BE DELETED. Marked as stopped 12/2008
- 8128: Waiting for input from SA3!. Marked as stopped 12/2008
- 8129: TO BE DELETED. Marked as stopped 12/2008
- 8130: -
- 8131: 14/02/2002 requirements are not clear/not receivedMarked as closed 12/2008 (was marked 95 complete)
- 8132: No clear indication on the end date. Put to Rel5 by AS.
- 8133: -
- 8134: Not identified
- 8135: -
- 8136: DAB 12.12.01 - % complete to 66%

| ID | WBS | Task | Duration | Start | Finish | Complete | Baseline start | Baseline finish | Baseline duration | Constraint | Resources | Work | Actual work | Acronym | WI rapporteur name | WI rapporteur e-mail | Release | MCC resp | Acronym_3GU_Export | TSG stopped | Impacted TSs and TRs |
| --- | --- | --- | --- | --- | --- | --- | --- | --- | --- | --- | --- | --- | --- | --- | --- | --- | --- | --- | --- | --- | --- |
| 8137 | 90.5 | **GERAN work for Intra Domain Connection of RAN Nodes to Multiple CN Nodes** | 101d | 2002-02-08 A | 2002-06-28 A | 100% | 2002-02-08 | 2002-06-28 | 101d |  | GP | 4848h | 4848h | IDCRAN-GERAN | Ericsson | ingemar.backlund@era.ericsson.se | Rel-5 | Paolo | IDCRAN-GERAN |  |  |
| 8138 | 90.5.1 | Stage 2 (changes to ) | 101d | 2002-02-08 A | 2002-06-28 A | 100% | 2002-02-08 | 2002-06-28 | 101d | finish no earlier than 2002-06-28 | G1 | 808h | 808h |  |  |  | Rel-5 | Paolo |  |  |  |
| 8139 | 90.5.2 | 43.051 Introduction of support for IDNNS in GERAN Iu mode | 101d | 2002-02-08 A | 2002-06-28 A | 100% | 2002-02-08 | 2002-06-28 | 101d | finish no earlier than 2002-06-28 | G1 | 808h | 808h |  |  |  | Rel-5 | Paolo |  |  |  |
| 8140 | 90.5.3 | Stage 3 (changes to ) | 101d | 2002-02-08 A | 2002-06-28 A | 100% | 2002-02-08 | 2002-06-28 | 101d | finish no earlier than 2002-06-28 | G2 | 808h | 808h |  |  |  | Rel-5 | Gert |  |  |  |
| 8141 | 90.5.4 | 48.016 Use of Gb interface concepts when a network applies IDNNS | 101d | 2002-02-08 A | 2002-06-28 A | 100% | 2002-02-08 | 2002-06-28 | 101d | finish no earlier than 2002-06-28 | G2 | 808h | 808h |  |  |  | Rel-5 | Gert |  |  |  |
| 8142 | 90.5.5 | 48.018 Include MSC/VLR identity in CS IMSI paging | 101d | 2002-02-08 A | 2002-06-28 A | 100% | 2002-02-08 | 2002-06-28 | 101d | finish no earlier than 2002-06-28 | G2 | 808h | 808h |  |  |  | Rel-5 | Gert |  |  |  |
| 8143 | 91 | **Deleted - GERAN improvements 3 (new transport layer on interface A)** | 446d | 2001-04-06 A | 2002-12-20 A | 100% | 2001-04-06 | 2002-12-20 | 446d |  | GP | 14272h | 14272h | GEIMP3 |  |  | Rel-5 | Paolo | GEIMP3 | SP-69 |  |
| 8144 | 91.1 | **Deleted - Evolution of the transport for A** | 446d | 2001-04-06 A | 2002-12-20 A | 100% | 2001-04-06 | 2002-12-20 | 446d |  | GP | 10704h | 10704h | GEIMP3-EtA |  |  | Rel-5 | Paolo | GEIMP3-EtA | GP-12 |  |
| 8145 | 91.1.1 | Deleted - Definition of a new A/Ater interface Transport Layer option based on the Iu Interface Transport Layer | 446d | 2001-04-06 A | 2002-12-20 A | 100% | 2001-04-06 | 2002-12-20 | 446d | finish no earlier than 2002-12-20 | GP | 3568h | 3568h |  |  |  | Rel-5 | Paolo |  | GP-12 |  |
| 8146 | 91.1.2 | Deleted - Adaptation of the Layer 3 BSSMAP procedures as required | 446d | 2001-04-06 A | 2002-12-20 A | 100% | 2001-04-06 | 2002-12-20 | 446d | finish no earlier than 2002-12-20 | GP | 3568h | 3568h |  |  |  | Rel-5 | Paolo |  | GP-12 |  |
| 8147 | 92 | **Rel-5 Charging Management & Operations, Administration, Maintenance and Provisioning (OAM&P)** | 264d | 2001-09-10 A | 2002-09-12 A | 100% | 2001-09-10 | 2002-09-12 | 264d |  | S5 | 9976h | 9976h | OAM5 |  |  | Rel-5 | Mirko | OAM5 |  |  |
| 8148 | 92.1 | Rel-5 Principles, high level Requirements and Architecture | 205d | 2001-09-17 A | 2002-06-28 A | 100% | 2001-09-17 | 2002-06-28 | 205d | finish no earlier than 2002-06-28 | S5 | 1640h | 1640h |  | Motorola |  | Rel-5 | Mirko |  |  | 32.101; 32.102 |
| 8149 | 92.2 | Rel-5 Performance Management | 259d | 2001-09-17 A | 2002-09-12 A | 100% | 2001-09-17 | 2002-09-12 | 259d | finish no earlier than 2002-09-12 | S5 | 2072h | 2072h |  | Nortel |  | Rel-5 | Mirko |  |  | 32.4xy; 52.402 |
| 8150 | 92.3 | Rel-5 Charging Management | 264d | 2001-09-10 A | 2002-09-12 A | 100% | 2001-09-10 | 2002-09-12 | 264d | finish no earlier than 2002-09-12 | S5 | 2112h | 2112h |  | T-Mobile | Karl-Heinz.Nenner@T-MOBILE.DE | Rel-5 | Mirko |  |  | 32.200; 32.205; 32.215; 32.225; 32.235 |
| 8151 | 92.4 | Rel-5 Network Infrastructure Management | 255d | 2001-09-21 A | 2002-09-12 A | 100% | 2001-09-21 | 2002-09-12 | 255d | finish no earlier than 2002-09-12 | S5 | 2040h | 2040h |  | Ericsson | thomas.tovinger@ericsson.com | Rel-5 | Mirko |  |  | 32.6xy; 32.3xy |
| 8152 | 93 | **GERAN enhancements for streaming services 1 (RLC enhancements)** | 430d | 2000-11-06 A | 2002-06-28 A | 100% | 2000-11-06 | 2002-06-28 | 430d |  | GP | 8944h | 8944h |  |  |  | Rel-5 | Paolo |  |  |  |
| 8153 | 93.1 | Concept for GERAN enhancements for streaming services 1 (RLC enhancements) | 258d | 2000-11-06 A | 2001-10-31 A | 100% | 2000-11-06 | 2001-10-31 | 258d | finish no earlier than 2001-10-31 | GP | 2064h | 2064h |  |  |  | Rel-5 | Paolo |  |  |  |
| 8154 | 93.2 | RLC protocol enhancement (SDU Discard) | 430d | 2000-11-06 A | 2002-06-28 A | 100% | 2000-11-06 | 2002-06-28 | 430d | finish no earlier than 2002-06-28 | GP | 3440h | 3440h |  |  |  | Rel-5 | Paolo |  |  |  |
| 8155 | 94 | **GERAN enhancements for streaming services 2 (usage of ECSD)** | 430d | 2000-11-06 A | 2002-06-28 A | 100% | 2000-11-06 | 2002-06-28 | 430d |  | GP | 19840h | 19840h |  | Ericsson | Frank Muller | Rel-5 | Paolo |  |  |  |
| 8156 | 94.1 | Usage of ECSD Concept | 380d | 2000-11-06 A | 2002-04-19 A | 100% | 2000-11-06 | 2002-04-19 | 380d | finish no earlier than 2002-04-19 | GP | 3040h | 3040h |  |  |  | Rel-5 | Paolo |  |  |  |
| 8157 | 94.2 | Stage 2 for GERAN enhancements for streaming services 2 (usage of ECSD) | 380d | 2000-11-06 A | 2002-04-19 A | 100% | 2000-11-06 | 2002-04-19 | 380d | finish no earlier than 2002-04-19 | GP | 3040h | 3040h |  |  |  | Rel-5 | Paolo |  |  |  |
| 8158 | 94.3 | Stage 3 for GERAN enhancements for streaming services 2 (usage of ECSD) | 430d | 2000-11-06 A | 2002-06-28 A | 100% | 2000-11-06 | 2002-06-28 | 430d | finish no earlier than 2002-06-28 | GP | 3440h | 3440h |  |  |  | Rel-5 | Paolo |  |  |  |
| 8159 | 94.4 | RLC PDU formats | 430d | 2000-11-06 A | 2002-06-28 A | 100% | 2000-11-06 | 2002-06-28 | 430d | finish no earlier than 2002-06-28 | GP | 3440h | 3440h |  |  |  | Rel-5 | Paolo |  |  |  |
| 8160 | 94.5 | MAC header | 430d | 2000-11-06 A | 2002-06-28 A | 100% | 2000-11-06 | 2002-06-28 | 430d | finish no earlier than 2002-06-28 | GP | 3440h | 3440h |  |  |  | Rel-5 | Paolo |  |  |  |

Notes:
- 8137: Accept changes Gb over IP
- 8138: -
- 8139: -
- 8140: -
- 8141: Closed, accept changes for Gb over IP
- 8142: -
- 8143: Terminated - not standardized. Marked as stopped 12/2008
- 8144: TERMINATED - NOT STANDARDIZED. Marked as stopped 12/2008
- 8145: TERMINATED - NOT STANDARDIZED. Marked as stopped 12/2008
- 8146: TERMINATED - NOT STANDARDIZED. Marked as stopped 12/2008
- 8147: -
- 8148: -
- 8149: -
- 8150: -
- 8151: -
- 8152: -
- 8153: -
- 8154: -
- 8155: AWS, Nokia, Ericsson, Nortel, Siemens, Motorola, Vodafone
- 8156: -
- 8157: -
- 8158: -
- 8159: -
- 8160: -

| ID | WBS | Task | Duration | Start | Finish | Predecessors | Complete | Baseline start | Baseline finish | Baseline duration | Constraint | Resources | Work | Actual work | Acronym | WI rapporteur name | WI rapporteur e-mail | Release | MCC resp | Acronym_3GU_Export |
| --- | --- | --- | --- | --- | --- | --- | --- | --- | --- | --- | --- | --- | --- | --- | --- | --- | --- | --- | --- | --- |
| 8161 | 95 | **GERAN/UTRAN interface evolution 1 (evolution of Iu PS)** | 476d | 2000-09-01 A | 2002-06-28 A |  | 100% | 2000-09-01 | 2002-06-28 | 476d |  | GP; R3 | 22848h | 22848h | GERUEV1 | SBC | Marc Grant | Rel-5 | Paolo | GERUEV1 |
| 8162 | 95.1 | **Evolution of Iu ps** | 476d | 2000-09-01 A | 2002-06-28 A |  | 100% | 2000-09-01 | 2002-06-28 | 476d |  | GP; R3 | 15232h | 15232h | GERUEV1-IuPS |  |  | Rel-5 | Paolo | GERUEV1-IuPS |
| 8163 | 95.1.1 | Identification of GERAN requirements on Iu ps | 326d | 2000-09-01 A | 2001-11-30 A |  | 100% | 2000-09-01 | 2001-11-30 | 326d | finish no earlier than 2001-11-30 | GP; R3 | 5216h | 5216h |  |  |  | Rel-5 | Paolo |  |
| 8164 | 95.1.2 | Update of Evolution of Iu ps specifications | 150d | 2001-12-03 A | 2002-06-28 A | 8163 | 100% | 2001-12-03 | 2002-06-28 | 150d | finish no earlier than 2002-06-28 | GP; R3 | 2400h | 2400h |  |  |  | Rel-5 | Paolo |  |
| 8165 | 96 | **GERAN/UTRAN interface evolution 2 (evolution of Iu CS)** | 522d | 2000-06-29 A | 2002-06-28 A |  | 100% | 2000-06-29 | 2002-06-28 | 522d |  | GP; R3 | 31872h | 31872h | GERUEV2 |  |  | Rel-5 | Paolo | GERUEV2 |
| 8166 | 96.1 | **Evolution of Iu cs** | 522d | 2000-06-29 A | 2002-06-28 A |  | 100% | 2000-06-29 | 2002-06-28 | 522d |  | GP; R3 | 23520h | 23520h | GERUEV2-IuCS | Lucent | Krishna Balachandran | Rel-5 | Paolo | GERUEV2-IuCS |
| 8167 | 96.1.1 | Identification of GERAN requirements on Iu cs | 472d | 2000-06-29 A | 2002-04-19 A |  | 100% | 2000-06-29 | 2002-04-19 | 472d | finish no earlier than 2002-04-19 | GP; R3 | 7552h | 7552h |  |  |  | Rel-5 | Paolo |  |
| 8168 | 96.1.2 | Update of Evolution of Iu cs specifications | 476d | 2000-09-01 A | 2002-06-28 A |  | 100% | 2000-09-01 | 2002-06-28 | 476d | finish no earlier than 2002-06-28 | GP; R3 | 7616h | 7616h |  |  |  | Rel-5 | Paolo |  |
| 8169 | 97 | **End to End QoS for PS Domain including IMS** | 480d | 2000-08-28 A | 2002-06-28 A |  | 100% | 2000-08-28 | 2002-06-28 | 480d |  | S2; S5; N3 | 18272h | 18272h | E2EQoS | Ericsson | Johnson.oyama@era.ericcson.se | Rel-5 | Maurice | E2EQoS, Rel-5 |
| 8170 | 97.1 | E2E QoSConcept and Architecture | 178d | 2001-01-03 A | 2001-09-07 A |  | 100% | 2001-01-03 | 2001-09-07 | 178d | finish no earlier than 2001-09-07 | S2 | 1424h | 1424h |  |  |  | Rel-5 | Maurice |  |
| 8171 | 97.2 | E2E QoS interworking | 465d | 2000-08-28 A | 2002-06-07 A |  | 100% | 2000-08-28 | 2002-06-07 | 465d | finish no earlier than 2002-06-07 | N3 | 3720h | 3720h | E2EQoS-IW | Lucent | Daisuke Yokota (yokota@lucent.com) | Rel-5 | Gwiho | E2EQoS-IW |
| 8172 | 97.3 | QoS Management (Provisioning and Monitoring) | 201d | 2001-09-21 A | 2002-06-28 A |  | 100% | 2001-09-21 | 2002-06-28 | 201d | finish no earlier than 2002-06-28 | S5 | 1608h | 1608h | E2EQoS-OAM |  |  | Rel-5 | Mirko | E2EQoS-OAM |
| 8173 | 98 | **Rel-5 Messaging enhancements** | 467d | 2001-06-15 A | 2003-03-31 A |  | 100% | 2001-06-15 | 2003-03-31 | 467d |  | T2 | 19000h | 19000h | MESS5 |  |  | Rel-5 | Kimmo | MESS5 |
| 8174 | 98.1 | **Rel-5 Multimedia Messaging (MMS) enhancements** | 467d | 2001-06-15 A | 2003-03-31 A |  | 100% | 2001-06-15 | 2003-03-31 | 467d |  | T2 | 11688h | 11688h | MESS5-MMS | Siemens | Josef.Laumen@SAL.SIEMENS.DE | Rel-5 | Alain | MESS5-MMS |
| 8175 | 98.1.1 | Definition of service requirements for MESS5-MMS | 196d | 2001-06-15 A | 2002-03-15 A |  | 100% | 2001-06-15 | 2002-03-15 | 196d | finish no earlier than 2002-03-15 | S1 | 1568h | 1568h | MESS5-SR | Siemens | Josef.Laumen@SAL.SIEMENS.DE | Rel-5 | Alain | MESS5-SR |
| 8176 | 98.1.2 | Technical realization of MESS5-MMS | 256d | 2001-06-15 A | 2002-06-07 A |  | 100% | 2001-06-15 | 2002-06-07 | 256d | finish no earlier than 2002-06-07 | T2 | 2048h | 2048h |  | Siemens | Josef.Laumen@SAL.SIEMENS.DE | Rel-5 |  |  |
| 8177 | 98.1.3 | WAP Forum dependency: MM1 stage 3 | 467d | 2001-06-15 A | 2003-03-31 A |  | 100% | 2001-06-15 | 2003-03-31 | 467d | finish no earlier than 2003-03-31 | T2 | 3736h | 3736h |  |  |  | Rel-5 |  |  |
| 8178 | 98.1.4 | MMS formats and codecs for MESS5-MMS | 75d | 2001-12-03 A | 2002-03-15 A |  | 100% | 2001-12-03 | 2002-03-15 | 75d | finish no earlier than 2002-03-15 | S4 | 600h | 600h |  |  |  | Rel-5 | Paolo |  |
| 8179 | 98.2 | **Enhanced Messaging Service (EMS) enhancements** | 191d | 2001-06-15 A | 2002-03-08 A |  | 100% | 2001-06-15 | 2002-03-08 | 191d |  | T2 | 3584h | 3584h | MESS5-EMS | Ericsson | Alan.Baldwin@EML.ERICSSON.SE | Rel-5 | Kimmo | MESS5-EMS |
| 8180 | 98.2.1 | Definition of service requirements for Enhanced Messaging Service (EMS) enhancements | 66d | 2001-06-15 A | 2001-09-14 A |  | 100% | 2001-06-15 | 2001-09-14 | 66d | finish no earlier than 2001-09-14 | S1 | 528h | 528h |  | Ericsson | Alan.Baldwin@EML.ERICSSON.SE | Rel-5 | Alain |  |
| 8181 | 98.2.2 | Technical realization of Enhanced Messaging Service (EMS) enhancements | 191d | 2001-06-15 A | 2002-03-08 A |  | 100% | 2001-06-15 | 2002-03-08 | 191d | finish no earlier than 2002-03-08 | T2 | 1528h | 1528h |  | Ericsson | Alan.Baldwin@EML.ERICSSON.SE | Rel-5 | Kimmo |  |
| 8182 | 99 | **GERAN Inter BSC NACC improvements over the Gb Interface** | 215d | 2001-09-03 A | 2002-06-28 A |  | 100% | 2001-09-03 | 2002-06-28 | 215d |  | GP | 11184h | 11184h | GERNACC |  |  | Rel-5 | Paolo | GERNACC |
| 8183 | 99.1 | **Modification of core network protocols for GERAN Inter BSC NACC over Gb Interface** | 165d | 2001-09-03 A | 2002-04-19 A |  | 100% | 2001-09-03 | 2002-04-19 | 165d |  | N4; S2 | 7048h | 7048h | GERNACC-Cnmod |  |  | Rel-5 | Kimmo | GERNACC-Cnmod |
| 8184 | 99.1.1 | Stage 2 - Concept | 43d | 2001-09-03 A | 2001-10-31 A |  | 100% | 2001-09-03 | 2001-10-31 | 43d | finish no earlier than 2001-10-31 | N4; S2 | 688h | 688h |  |  |  | Rel-5 | Kimmo |  |
| 8185 | 99.1.2 | Stage 2 - 23.060 change - Definition of Inter BSC NACC | 165d | 2001-09-03 A | 2002-04-19 A |  | 100% | 2001-09-03 | 2002-04-19 | 165d | finish no earlier than 2002-04-19 | N4; S2 | 2640h | 2640h |  |  |  | Rel-5 | Kimmo |  |
| 8186 | 99.1.3 | Stage 3 (changes to TS 29.060) | 135d | 2001-09-03 A | 2002-03-08 A |  | 100% | 2001-09-03 | 2002-03-08 | 135d | finish no earlier than 2002-03-08 | N4 | 1080h | 1080h |  |  |  | Rel-5 | Kimmo |  |

Notes:
- 8161: SBC, Motorola, Nokia, Ericsson, Nortel
- 8162: -
- 8163: -
- 8164: -
- 8165: -
- 8166: Lucent, Ericsson, AWS, Nortel
- 8167: -
- 8168: -
- 8169: Acronym changed from "E2EQoS, Rel-5"
- 8170: - / Impacted TSs and TRs: 23.207
- 8171: [DAB - 30/07/02] - % complete to 95% (if we exclude Diffserv). Marked as closed 12/2008 (was marked 95% complete) / Impacted TSs and TRs: 29.208; 29.207; 27.060; 29.061; 24.008; 24.228; ; 24.229; 29.060; 29.163
- 8172: - / Impacted TSs and TRs: 32-series
- 8173: support of UAProf, so this in my opinion is 100% complete
- 8174: -
- 8175: - / Impacted TSs and TRs: 22.140
- 8176: stage 3 MM7 is missing / Impacted TSs and TRs: 23.140
- 8177: Marked as closed 12/2008 (was marked 80% complete)
- 8178: - / Impacted TSs and TRs: 26.140
- 8179: - / Impacted TSs and TRs: 23.040
- 8180: -
- 8181: - / Impacted TSs and TRs: 23.040
- 8182: -
- 8183: -
- 8184: -
- 8185: -
- 8186: IP 30/11/01: Input awaited from GERAN2 to CN4

| ID | WBS | Task | Duration | Start | Finish | Complete | Baseline start | Baseline finish | Baseline duration | Constraint | Resources | Work | Actual work | Acronym | Release | MCC resp | Acronym_3GU_Export | TSG stopped | WI rapporteur name | WI rapporteur e-mail |
| --- | --- | --- | --- | --- | --- | --- | --- | --- | --- | --- | --- | --- | --- | --- | --- | --- | --- | --- | --- | --- |
| 8187 | 99.2 | **Modification of Gb protocols for GERAN Inter BSC NACC over Gb Interface** | 151d | 2001-11-30 A | 2002-06-28 A | 100% | 2001-11-30 | 2002-06-28 | 151d |  | GP | 2416h | 2416h | GERNACC-Gbmod | Rel-5 | Paolo | GERNACC-Gbmod |  |  |  |
| 8188 | 99.2.1 | Stage 3 (changes to TS 48.018) | 151d | 2001-11-30 A | 2002-06-28 A | 100% | 2001-11-30 | 2002-06-28 | 151d | finish no earlier than 2002-06-28 | GP | 1208h | 1208h |  | Rel-5 | Paolo |  |  |  |  |
| 8189 | 100 | **Enhanced Power Control** | 540d | 2001-11-26 A | 2003-12-19 A | 100% | 2001-11-26 | 2003-12-19 | 540d |  | GP | 12840h | 12840h | EPC | Rel-5 | Paolo | EPC |  |  |  |
| 8190 | 100.1 | Realization of Enhanced power control and signalling support | 5d | 2001-11-26 A | 2001-11-30 A | 100% | 2001-11-26 | 2001-11-30 | 5d | finish no earlier than 2001-11-30 | GP | 40h | 40h |  | Rel-5 | Paolo |  |  |  |  |
| 8191 | 100.2 | Deleted - GERAN MS Conformance test for Enhanced Power Control | 530d | 2001-12-10 A | 2003-12-19 A | 100% | 2001-12-10 | 2003-12-19 | 530d | finish no earlier than 2003-12-19 | GP | 4240h | 4240h |  | Rel-5 | Paolo |  | GP-17 |  |  |
| 8192 | 100.3 | Deleted - GERAN BTS Conformance test for Enhanced Power Control | 530d | 2001-12-10 A | 2003-12-19 A | 100% | 2001-12-10 | 2003-12-19 | 530d | finish no earlier than 2003-12-19 | GP | 4240h | 4240h |  | Rel-5 | Paolo |  | GP-17 |  |  |
| 8193 | 101 | **8PSK AMR HR** | 530d | 2001-12-10 A | 2003-12-19 A | 100% | 2001-12-10 | 2003-12-19 | 530d |  | GP | 21080h | 21080h | 8PSK-AH | Rel-5 | Paolo | 8PSK-AH |  |  |  |
| 8194 | 101.1 | **Definition of channel coding, performance requirements and signalling support** | 145d | 2001-12-10 A | 2002-06-28 A | 100% | 2001-12-10 | 2002-06-28 | 145d |  | GP | 10440h | 10440h |  | Rel-5 | Paolo |  |  |  |  |
| 8195 | 101.1.1 | Concept | 145d | 2001-12-10 A | 2002-06-28 A | 100% | 2001-12-10 | 2002-06-28 | 145d | finish no earlier than 2002-06-28 | GP | 1160h | 1160h |  | Rel-5 | Paolo |  |  |  |  |
| 8196 | 101.1.2 | Changes to 44.018 | 145d | 2001-12-10 A | 2002-06-28 A | 100% | 2001-12-10 | 2002-06-28 | 145d | finish no earlier than 2002-06-28 | G2 | 1160h | 1160h |  | Rel-5 | Gert |  |  |  |  |
| 8197 | 101.1.3 | Changes to 45.001 | 145d | 2001-12-10 A | 2002-06-28 A | 100% | 2001-12-10 | 2002-06-28 | 145d | finish no earlier than 2002-06-28 | G1 | 1160h | 1160h |  | Rel-5 | Paolo |  |  |  |  |
| 8198 | 101.1.4 | Changes to 45.002 | 145d | 2001-12-10 A | 2002-06-28 A | 100% | 2001-12-10 | 2002-06-28 | 145d | finish no earlier than 2002-06-28 | G1 | 1160h | 1160h |  | Rel-5 | Paolo |  |  |  |  |
| 8199 | 101.1.5 | Changes to 45.003 | 145d | 2001-12-10 A | 2002-06-28 A | 100% | 2001-12-10 | 2002-06-28 | 145d | finish no earlier than 2002-06-28 | G1 | 1160h | 1160h |  | Rel-5 | Paolo |  |  |  |  |
| 8200 | 101.1.6 | Changes to 45.005 | 145d | 2001-12-10 A | 2002-06-28 A | 100% | 2001-12-10 | 2002-06-28 | 145d | finish no earlier than 2002-06-28 | G1 | 1160h | 1160h |  | Rel-5 | Paolo |  |  |  |  |
| 8201 | 101.1.7 | Changes to 24.008 | 145d | 2001-12-10 A | 2002-06-28 A | 100% | 2001-12-10 | 2002-06-28 | 145d | finish no earlier than 2002-06-28 | G2 | 1160h | 1160h |  | Rel-5 | Gert |  |  |  |  |
| 8202 | 101.1.8 | Changes to 48.058 | 145d | 2001-12-10 A | 2002-06-28 A | 100% | 2001-12-10 | 2002-06-28 | 145d | finish no earlier than 2002-06-28 | G2 | 1160h | 1160h |  | Rel-5 | Gert |  |  |  |  |
| 8203 | 101.2 | Deleted - GERAN MS Conformance test for 8PSK HR | 530d | 2001-12-10 A | 2003-12-19 A | 100% | 2001-12-10 | 2003-12-19 | 530d | finish no earlier than 2003-12-19 | GP | 4240h | 4240h |  | Rel-5 | Paolo |  | GP-17 |  |  |
| 8204 | 101.3 | GERAN BTS Conformance test for 8PSK HR | 270d | 2001-12-10 A | 2002-12-20 A | 100% | 2001-12-10 | 2002-12-20 | 270d | finish no earlier than 2002-12-20 | GP | 2160h | 2160h |  | Rel-5 | Paolo |  |  |  |  |
| 8205 | 102 | Service Change and UDI Fallback | 175d | 2001-10-08 A | 2002-06-07 A | 100% | 2001-10-08 | 2002-06-07 | 175d | finish no earlier than 2002-06-07 | N3 | 1400h | 1400h | SCUDIF | Rel-5 | Gwiho | SCUDIF |  | Ericsson | Rune.Werner.Wiik@ericsson.no |
| 8206 | 103 | **Rel-5 USIM toolkit enhancements** | 865d | 2000-06-05 A | 2003-09-26 A | 100% | 2000-06-05 | 2003-09-26 | 865d |  | T3; S1 | 36776h | 36776h | USAT5 | Rel-5 | Xavier | USAT1, USAT1-Interpr, USAT1LocLnk |  | G & D | Michael Meyer |
| 8207 | 103.1 | Deleted - Test specification for USIM toolkit security mechanisms | 349d | 2002-05-28 A | 2003-09-26 A | 100% | 2002-05-28 | 2003-09-26 | 349d | finish no earlier than 2003-09-26 | T3 | 2792h | 2792h |  | Rel-5 | Xavier |  | TP-21 | Gemplus | Sophie Viallet |
| 8208 | 103.2 | **Protocol Standardisation of a SIM Toolkit Interpreter** | 688d | 2000-06-05 A | 2003-01-22 A | 100% | 2000-06-05 | 2003-01-22 | 688d |  | T3; T2 | 18016h | 18016h |  | Rel-5 | Xavier |  |  | G & D | Michael Meyer |
| 8209 | 103.2.1 | Stage 1 for Protocol Standardisation of a SIM Toolkit Interpreter | 205d | 2000-06-05 A | 2001-03-16 A | 100% | 2000-06-05 | 2001-03-16 | 205d | finish no earlier than 2001-03-16 | T3 | 1640h | 1640h |  | Rel-5 | Xavier |  |  |  |  |
| 8210 | 103.2.2 | Stage 2 and 3 | 308d | 2001-01-03 A | 2002-03-08 A | 100% | 2001-01-03 | 2002-03-08 | 308d | finish no earlier than 2002-03-08 | T3 | 2464h | 2464h |  | Rel-5 | Xavier |  |  |  |  |
| 8211 | 103.2.3 | Test specification for Protocol Standardisation of a SIM Toolkit Interpreter | 363d | 2001-09-03 A | 2003-01-22 A | 100% | 2001-09-03 | 2003-01-22 | 363d | finish no earlier than 2003-01-22 | T3 | 2904h | 2904h |  | Rel-5 | Xavier |  |  | Gemplus | Gérald MAUNIER |

Notes:
- 8187: -
- 8188: -
- 8189: -
- 8190: Completed 11/2001
- 8191: Not started. Marked as stopped 12/2008
- 8192: Not started. Marked as stopped 12/2008
- 8193: Completed for Rel-5
- 8194: -
- 8195: -
- 8196: -
- 8197: -
- 8198: -
- 8199: -
- 8200: -
- 8201: -
- 8202: -
- 8203: Marked as stopped 12/2008
- 8204: -
- 8205: - / Impacted TSs and TRs: 29.007; 27.001; 24.008
- 8206: Acronym changed from USAT1, USAT1-Interpr, USAT1LocLnk / Impacted TSs and TRs: 22.038; 31.111 (USAT1); 22.038; 03.19; 03.48 (USAT1LocLnk); 23.048 (USAT1SM); 43.019 (USAT1APIJAVA)
- 8207: Marked as stopped 12/2008
- 8208: 28/5/2001: T3-19 proposed that since the stage 2 and 3 will not be presented to TP-12 for approval as expected, the WI will be moved to rel-5, with completion expected at TP-13. / Impacted TSs and TRs: T2 27.103
- 8209: 5/10/2001: Stage one comepeted at TP-12. / Impacted TSs and TRs: 31.112; 31.113; 31.114
- 8210: 5/10/2001: TS 31.112 and 31.113 approved at TP-13. TS 31.114 to be presented to TP-14. / Impacted TSs and TRs: 31.112; 31.113; 31.114
- 8211: 5/10/2001: Work started on test specification. Marked as closed 12/2008 (was marked 12% complete)

| ID | WBS | Task | Type | Duration | Start | Finish | Complete | Baseline start | Baseline finish | Baseline duration | Constraint | Resources | Work | Actual work | Acronym | WI rapporteur name | WI rapporteur e-mail | Release | MCC resp | Acronym_3GU_Export | TSG stopped |
| --- | --- | --- | --- | --- | --- | --- | --- | --- | --- | --- | --- | --- | --- | --- | --- | --- | --- | --- | --- | --- | --- |
| 8212 | 103.4 | **(U)SIM API** |  | 133d | 2002-03-20 A | 2002-09-20 A | 100% | 2002-03-20 | 2002-09-20 | 133d |  | T3 | 2128h | 2128h | USAT5-API | Microelectrónica Española | Mario Pérez | Rel-5 | Xavier | USAT1-API, TEI4 |  |
| 8213 | 103.4.1 | Rel-5 Java API Test specification |  | 133d | 2002-03-20 A | 2002-09-20 A | 100% | 2002-03-20 | 2002-09-20 | 133d | finish no earlier than 2002-09-20 | T3 | 1064h | 1064h |  | Microelectrónica Española | Mario Pérez | Rel-5 | Xavier |  |  |
| 8214 | 104 | (Small) Technical Enhancements and Improvements for Rel-5 | milestone | 0d? | 2000-01-03 A | 2000-01-03 A | 100% | 2000-01-03 | 2000-01-03 | 0d? |  | SP; CP; RP; GP |  |  | TEI5 |  |  | Rel-5 | all | TEI5 |  |
| 8215 | 2483 | Test - (Small) Technical Enhancements and Improvements for Rel-5 |  | 2349d? | 2000-01-03 A | 2008-12-31 A | 100% | 2000-01-03 | 2008-12-31 | 2349d? | finish no earlier than 2008-12-31 | R5; T1 | 37584h | 37584h | TEI5_Test |  |  | Rel-5 | Ingbert | TEI5_Test |  |
| 8216 | 105 | Technical Report on UE Functionality Split |  | 87d | 2000-01-03 A | 2000-05-01 A | 100% | 2000-01-03 | 2000-05-01 | 87d |  | S1 | 688h | 688h | UESPLIT | Motorola | jian.j.wu@motorola.com | Rel-5 | Alain | UESPLIT |  |
| 8217 | 106 | **User Equipment Management** |  | 267d | 2001-06-21 A | 2002-06-28 A | 100% | 2001-06-21 | 2002-06-28 | 267d |  | S5 | 3752h | 3752h | UEM | Vodafone | john.mudge@vf.vodafone.co.uk | Rel-5 | Mirko | UEM |  |
| 8218 | 106.1 | FS on User Equipment (UE) Management |  | 267d | 2001-06-21 A | 2002-06-28 A | 100% | 2001-06-21 | 2002-06-28 | 267d | finish no earlier than 2002-06-28 | S5 | 2136h | 2136h | OAM-UEM | Vodafone | john.mudge@vf.vodafone.co.uk | Rel-5 | Mirko | OAM-UEM |  |
| 8219 | 107 | **Flow control supporting an MS with multiple data flows with different QoS over the Gb interface** |  | 50d | 2002-06-24 A | 2002-08-30 A | 100% | 2002-06-24 | 2002-08-30 | 50d |  | GP | 1288h | 1288h | FlowCon | Ericsson | ingemar.backlund@era.ericsson.se | Rel-5 | Paolo | FlowCon |  |
| 8220 | 107.1 | **Update of stage 2 specifications** |  | 50d | 2002-06-24 A | 2002-08-30 A | 100% | 2002-06-24 | 2002-08-30 | 50d |  | GP | 808h | 808h |  |  |  | Rel-5 | Paolo |  |  |
| 8221 | 107.1.1 | Concept document 23.060 (changes to) |  | 46d | 2002-06-28 A | 2002-08-30 A | 100% | 2002-06-28 | 2002-08-30 | 46d | finish no earlier than 2002-08-30 | S2 | 368h | 368h |  |  |  | Rel-5 | Maurice |  |  |
| 8222 | 107.1.2 | Flow Control |  | 5d | 2002-06-24 A | 2002-06-28 A | 100% | 2002-06-24 | 2002-06-28 | 5d | finish no earlier than 2002-06-28 | GP | 40h | 40h |  |  |  | Rel-5 | Paolo |  |  |
| 8223 | 107.2 | **Modification of BSSGP protocol** |  | 5d | 2002-06-24 A | 2002-06-28 A | 100% | 2002-06-24 | 2002-06-28 | 5d |  | GP | 80h | 80h |  | Ericsson | ingemar.backlund@era.ericsson.se | Rel-5 | Paolo |  |  |
| 8224 | 107.2.1 | Stage 3 (changes to 48.018) |  | 5d | 2002-06-24 A | 2002-06-28 A | 100% | 2002-06-24 | 2002-06-28 | 5d | finish no earlier than 2002-06-28 | G2 | 40h | 40h |  |  |  | Rel-5 | Gert |  |  |
| 8225 | 108 | **Deleted - Multiple TBF in A/Gb mode - Phase 1 (MULTBF)** |  | 421d | 2002-04-19 A | 2003-11-28 A | 100% | 2002-04-19 | 2003-11-28 | 421d |  | GP | 17480h | 17480h |  | Ericsson | gunnar.mildh@era.ericsson.se | Rel-5 | Paolo |  | GP-17 |
| 8226 | 108.1 | **Deleted - Multiple TBF in A/Gb mode - Core (MULTBF-Agbmode)** |  | 351d | 2002-04-19 A | 2003-08-22 A | 100% | 2002-04-19 | 2003-08-22 | 351d |  | GP | 8112h | 8112h |  |  |  | Rel-5 | Paolo |  | GP-17 |
| 8227 | 108.1.1 | Deleted - Multiple TBF Concept paper |  | 351d | 2002-04-19 A | 2003-08-22 A | 100% | 2002-04-19 | 2003-08-22 | 351d | finish no earlier than 2003-08-22 | GP | 2808h | 2808h |  |  |  | Rel-5 | Paolo |  | GP-17 |
| 8228 | 108.1.2 | Deleted - Multiple TBF Stage 2 (43.064) CRs |  | 156d | 2002-04-19 A | 2002-11-22 A | 100% | 2002-04-19 | 2002-11-22 | 156d | finish no earlier than 2002-11-22 | G1 | 1248h | 1248h |  |  |  | Rel-5 | Paolo |  | GP-12 |
| 8229 | 108.1.3 | Deleted - Multiple TBF Stage 3 (44.060) CRs |  | 156d | 2002-04-19 A | 2002-11-22 A | 100% | 2002-04-19 | 2002-11-22 | 156d | finish no earlier than 2002-11-22 | G2 | 1248h | 1248h |  |  |  | Rel-5 | Gert |  | GP-12 |
| 8230 | 108.2 | **Deleted - Multiple TBF in A/Gb mode - Phase 1 – MS testing** |  | 375d | 2002-06-24 A | 2003-11-28 A | 100% | 2002-06-24 | 2003-11-28 | 375d |  | GP | 6000h | 6000h |  | Ericsson | ingemar.backlund@era.ericsson.se | Rel-5 | Paolo |  | GP-17 |
| 8231 | 108.2.1 | Deleted - MS conformance tests for Multiple TBF in A/Gb mode |  | 375d | 2002-06-24 A | 2003-11-28 A | 100% | 2002-06-24 | 2003-11-28 | 375d | finish no earlier than 2003-11-28 | G4 | 3000h | 3000h |  |  |  | Rel-5 | Paolo |  | GP-17 |
| 8232 | 109 | **Alignment of 3G functional split and Iu** |  | 922d | 2000-06-08 A | 2003-12-19 A | 100% | 2000-06-08 | 2003-12-19 | 922d |  | GP | 165704h | 165704h | GER3GAL | Ericsson | Frank Muller | Rel-5 | Paolo | GER3GAL |  |
| 8233 | 109.1 | **GERAN user / control plane** |  | 540d | 2000-08-07 A | 2002-08-30 A | 100% | 2000-08-07 | 2002-08-30 | 540d |  | GP | 36232h | 36232h | GER3GAL-GUCOPL | Ericsson | Frank Muller | Rel-5 | Paolo | GER3GAL-GUCOPL |  |
| 8234 | 109.1.1 | **Alignment with UMTS bearer concept** |  | 540d | 2000-08-07 A | 2002-08-30 A | 100% | 2000-08-07 | 2002-08-30 | 540d |  | GP | 24952h | 24952h |  |  |  | Rel-5 | Paolo |  |  |
| 8235 | 109.1.1.1 | Enhanced power control - for Alignment with UMTS bearer concept |  | 1d | 2001-08-31 A | 2001-08-31 A | 100% | 2001-08-31 | 2001-08-31 | 1d | finish no earlier than 2001-08-31 | GP | 8h | 8h |  |  |  | Rel-5 | Paolo |  |  |
| 8236 | 109.1.1.2 | Stage 2 - for Alignment with UMTS bearer concept |  | 235d | 2000-08-07 A | 2001-06-29 A | 100% | 2000-08-07 | 2001-06-29 | 235d | finish no earlier than 2001-06-29 | GP | 1880h | 1880h |  |  |  | Rel-5 | Paolo |  |  |
| 8237 | 109.1.1.3 | Adoption of the UTRAN PDCP |  | 295d | 2000-11-06 A | 2001-12-21 A | 100% | 2000-11-06 | 2001-12-21 | 295d | finish no earlier than 2001-12-21 | GP | 2360h | 2360h |  |  |  | Rel-5 | Paolo |  |  |
| 8238 | 109.1.1.4 | Development of RLC / MAC |  | 261d | 2001-08-31 A | 2002-08-30 A | 100% | 2001-08-31 | 2002-08-30 | 261d | finish no earlier than 2002-08-30 | GP | 2088h | 2088h |  |  |  | Rel-5 | Paolo |  |  |
| 8239 | 109.1.1.5 | Development of GERAN RRC |  | 266d | 2001-06-22 A | 2002-06-28 A | 100% | 2001-06-22 | 2002-06-28 | 266d | finish no earlier than 2002-06-28 | GP | 2128h | 2128h |  |  |  | Rel-5 | Paolo |  |  |
| 8240 | 109.1.1.6 | Ciphering and integrity protection concept paper |  | 166d | 2001-08-31 A | 2002-04-19 A | 100% | 2001-08-31 | 2002-04-19 | 166d | finish no earlier than 2002-04-19 | GP | 1328h | 1328h |  |  |  | Rel-5 | Paolo |  |  |
| 8241 | 109.1.1.7 | Multiple TBF or equivalent Concept paper |  | 116d | 2001-08-31 A | 2002-02-08 A | 100% | 2001-08-31 | 2002-02-08 | 116d | finish no earlier than 2002-02-08 | GP | 928h | 928h |  |  |  | Rel-5 | Paolo |  |  |
| 8242 | 109.1.1.8 | Paging concept |  | 166d | 2001-08-31 A | 2002-04-19 A | 100% | 2001-08-31 | 2002-04-19 | 166d | finish no earlier than 2002-04-19 | GP | 1328h | 1328h |  |  |  | Rel-5 | Paolo |  |  |
| 8243 | 109.1.1.9 | Dedicated Physical subchannels, includes traffic and control channels |  | 66d | 2001-08-31 A | 2001-11-30 A | 100% | 2001-08-31 | 2001-11-30 | 66d | finish no earlier than 2001-11-30 | GP | 528h | 528h |  |  |  | Rel-5 | Paolo |  |  |
| 8244 | 109.1.1.10 | Iu support and broadcast concept |  | 166d | 2001-08-31 A | 2002-04-19 A | 100% | 2001-08-31 | 2002-04-19 | 166d | finish no earlier than 2002-04-19 | GP | 1328h | 1328h |  |  |  | Rel-5 | Paolo |  |  |
| 8245 | 109.1.1.11 | Impact of using RLC instead of LAPDm concept |  | 116d | 2001-08-31 A | 2002-02-08 A | 100% | 2001-08-31 | 2002-02-08 | 116d | finish no earlier than 2002-02-08 | GP | 928h | 928h |  |  |  | Rel-5 | Paolo |  |  |
| 8246 | 109.1.1.12 | Contention resolution, mobile station identity, and access concept |  | 66d | 2001-08-31 A | 2001-11-30 A | 100% | 2001-08-31 | 2001-11-30 | 66d | finish no earlier than 2001-11-30 | GP | 528h | 528h |  |  |  | Rel-5 | Paolo |  |  |
| 8247 | 109.1.1.13 | PDCP concept |  | 166d | 2001-08-31 A | 2002-04-19 A | 100% | 2001-08-31 | 2002-04-19 | 166d | finish no earlier than 2002-04-19 | GP | 1328h | 1328h |  |  |  | Rel-5 | Paolo |  |  |
| 8248 | 109.1.1.14 | Downlink delayed TBF release |  | 261d | 2001-08-31 A | 2002-08-30 A | 100% | 2001-08-31 | 2002-08-30 | 261d | finish no earlier than 2002-08-30 | GP | 2088h | 2088h |  |  |  | Rel-5 | Paolo |  |  |
| 8249 | 109.1.1.15 | Add transparent RLC Concept |  | 116d | 2001-08-31 A | 2002-02-08 A | 100% | 2001-08-31 | 2002-02-08 | 116d | finish no earlier than 2002-02-08 | GP | 928h | 928h |  |  |  | Rel-5 | Paolo |  |  |
| 8250 | 109.1.1.16 | Handover concept |  | 116d | 2001-08-31 A | 2002-02-08 A | 100% | 2001-08-31 | 2002-02-08 | 116d | finish no earlier than 2002-02-08 | GP | 928h | 928h |  |  |  | Rel-5 | Paolo |  |  |

Notes:
- 8212: 8/3/2001: test spec is based on R99 core spec, so deleted from Workplan. Acronym changed from USAT1-API, TEI4
- 8213: - / Impacted TSs and TRs: 51.013
- 8214: "Joker" WI, to be used for a Rel 5 CR not related to any feature and with very limited impact on the system
- 8215: "Joker" WI, to be used for small modifications applicable to Rel 5 conformance testing. Moved in from Stoyan/testing WP. / Impacted TSs and TRs: 34.108; 34.109; 34.121-1; 34.121-2; 34.122; 34.123-1; 34.123-2; 34.123-3; 34.171; 34.229-1; 34.229-2; 34.229-3
- 8216: - / Impacted TSs and TRs: New 22.944
- 8217: - / Impacted TSs and TRs: 32.802
- 8218: - / Impacted TSs and TRs: 32.802
- 8219: 50101 -> 50201
- 8220: 50102 -> 50202
- 8221: -
- 8222: 50103 -> 50203
- 8223: 50104 -> 50204
- 8224: -
- 8225: GP#17 Nov 2003 Moved to Rel-6 as UID_50600 MULTBF (Only Multiple TBF Concept paper produced in Rel-5)
- 8226: Marked as closed 12/2008 (was marked 26% complete)
- 8227: Marked as closed 12/2008 (was marked 50% complete)
- 8228: Marked as stopped 12/2008
- 8229: Marked as stopped 12/2008
- 8230: 08/08: duplicate UID_50106=-> 50206. Marked as stopped 12/2008
- 8231: Not started. Marked as stopped 12/2008
- 8232: AWS, Nokia, Ericsson, Nortel, Siemens, Vodafone
- 8233: AWS, Nokia, Ericsson, Nortel, Siemens, Vodafone
- 8234: -
- 8235: -
- 8236: -
- 8237: Responsible is GERAN¦RAN WG2 help may be needed.
- 8238: -
- 8239: -
- 8240: -
- 8241: -
- 8242: -
- 8243: -
- 8244: -
- 8245: -
- 8246: -
- 8247: -
- 8248: -
- 8249: -
- 8250: -

| ID | WBS | Task | Duration | Start | Finish | Complete | Baseline start | Baseline finish | Baseline duration | Constraint | Resources | Work | Actual work | Release | MCC resp | Acronym | WI rapporteur name | WI rapporteur e-mail | Acronym_3GU_Export |
| --- | --- | --- | --- | --- | --- | --- | --- | --- | --- | --- | --- | --- | --- | --- | --- | --- | --- | --- | --- |
| 8251 | 109.1.2 | **Physical layer alignment with UMTS bearer concept** | 280d | 2000-11-06 A | 2001-11-30 A | 100% | 2000-11-06 | 2001-11-30 | 280d |  | GP | 6960h | 6960h | Rel-5 | Paolo |  |  |  |  |
| 8252 | 109.1.2.1 | PDTCH/TCH in 45.003 | 155d | 2000-11-06 A | 2001-06-08 A | 100% | 2000-11-06 | 2001-06-08 | 155d | finish no earlier than 2001-06-08 | GP | 1240h | 1240h | Rel-5 | Paolo |  |  |  |  |
| 8253 | 109.1.2.2 | Control channels in 45.003 | 155d | 2000-11-06 A | 2001-06-08 A | 100% | 2000-11-06 | 2001-06-08 | 155d | finish no earlier than 2001-06-08 | GP | 1240h | 1240h | Rel-5 | Paolo |  |  |  |  |
| 8254 | 109.1.2.3 | Receiver performance in 45.005 for PDTCH/TCH and control channels | 280d | 2000-11-06 A | 2001-11-30 A | 100% | 2000-11-06 | 2001-11-30 | 280d | finish no earlier than 2001-11-30 | GP | 2240h | 2240h | Rel-5 | Paolo |  |  |  |  |
| 8255 | 109.2 | **Iu rg interface** | 430d | 2000-11-06 A | 2002-06-28 A | 100% | 2000-11-06 | 2002-06-28 | 430d |  | GP; RP | 61920h | 61920h | Rel-5 | Paolo | GER3GAL-Iurg | Ericsson | Frank Muller | GER3GAL-Iurg |
| 8256 | 109.2.1 | **Inter BSS interface** | 430d | 2000-11-06 A | 2002-06-28 A | 100% | 2000-11-06 | 2002-06-28 | 430d |  | GP; RP | 24080h | 24080h | Rel-5 | Paolo |  |  |  |  |
| 8257 | 109.2.1.1 | Identification of requirements for Inter BSS interface | 430d | 2000-11-06 A | 2002-06-28 A | 100% | 2000-11-06 | 2002-06-28 | 430d | finish no earlier than 2002-06-28 | GP | 3440h | 3440h | Rel-5 | Paolo |  |  |  |  |
| 8258 | 109.2.1.2 | Stage 2 for Inter BSS interface | 430d | 2000-11-06 A | 2002-06-28 A | 100% | 2000-11-06 | 2002-06-28 | 430d | finish no earlier than 2002-06-28 | GP | 3440h | 3440h | Rel-5 | Paolo |  |  |  |  |
| 8259 | 109.2.1.3 | Adoption of relevant parts from Iur - for Inter BSS interface | 430d | 2000-11-06 A | 2002-06-28 A | 100% | 2000-11-06 | 2002-06-28 | 430d | finish no earlier than 2002-06-28 | GP | 3440h | 3440h | Rel-5 | Paolo |  |  |  |  |
| 8260 | 109.2.1.4 | Complementation with GERAN specifics - for Inter BSS interface | 430d | 2000-11-06 A | 2002-06-28 A | 100% | 2000-11-06 | 2002-06-28 | 430d | finish no earlier than 2002-06-28 | GP | 3440h | 3440h | Rel-5 | Paolo |  |  |  |  |
| 8261 | 109.2.1.5 | Stage 3 for Inter BSS interface | 430d | 2000-11-06 A | 2002-06-28 A | 100% | 2000-11-06 | 2002-06-28 | 430d | finish no earlier than 2002-06-28 | GP | 3440h | 3440h | Rel-5 | Paolo |  |  |  |  |
| 8262 | 109.2.2 | **Inter BSS-RNS interface** | 430d | 2000-11-06 A | 2002-06-28 A | 100% | 2000-11-06 | 2002-06-28 | 430d |  | GP; RP | 30960h | 30960h | Rel-5 | Paolo |  |  |  |  |
| 8263 | 109.2.2.1 | Identification of requirements for Inter BSS-RNS interface | 430d | 2000-11-06 A | 2002-06-28 A | 100% | 2000-11-06 | 2002-06-28 | 430d | start no earlier than 2000-11-06 | GP; R3 | 6880h | 6880h | Rel-5 | Paolo |  |  |  |  |
| 8264 | 109.2.2.2 | Stage 2 for Inter BSS-RNS interface | 430d | 2000-11-06 A | 2002-06-28 A | 100% | 2000-11-06 | 2002-06-28 | 430d | finish no earlier than 2002-06-28 | GP; R3 | 6880h | 6880h | Rel-5 | Paolo |  |  |  |  |
| 8265 | 109.2.2.3 | Adoption of relevant parts from Iur - for Inter BSS-RNS interface | 430d | 2000-11-06 A | 2002-06-28 A | 100% | 2000-11-06 | 2002-06-28 | 430d | finish no earlier than 2002-06-28 | GP; R3 | 6880h | 6880h | Rel-5 | Paolo |  |  |  |  |
| 8266 | 109.2.2.4 | Complementation with GERAN specifics - for Inter BSS-RNS interface | 107.5d | 2002-01-30 A | 2002-06-28 A | 100% | 2002-01-30 | 2002-06-28 | 107.5d | finish no earlier than 2002-06-28 | GP; R3 | 1720h | 1720h | Rel-5 | Paolo |  |  |  |  |
| 8267 | 109.2.2.5 | Stage 3 for Inter BSS-RNS interface | 107.5d | 2002-01-30 A | 2002-06-28 A | 100% | 2002-01-30 | 2002-06-28 | 107.5d | finish no earlier than 2002-06-28 | GP; R3 | 1720h | 1720h | Rel-5 | Paolo |  |  |  |  |
| 8268 | 109.3 | **Voice over GERAN PS and CS concept** | 430d | 2000-11-06 A | 2002-06-28 A | 100% | 2000-11-06 | 2002-06-28 | 430d |  | GP; R3 | 35200h | 35200h | Rel-5 | Paolo |  |  |  |  |
| 8269 | 109.3.1 | Architecture for A, Iu cs and Iu ps | 430d | 2000-11-06 A | 2002-06-28 A | 100% | 2000-11-06 | 2002-06-28 | 430d | finish no earlier than 2002-06-28 | GP; R3 | 6880h | 6880h | Rel-5 | Paolo |  |  |  |  |
| 8270 | 109.3.2 | Transcoder position/operation | 115d | 2000-11-06 A | 2001-04-13 A | 100% | 2000-11-06 | 2001-04-13 | 115d | finish no earlier than 2001-04-13 | GP | 920h | 920h | Rel-5 | Paolo |  |  |  |  |
| 8271 | 109.3.3 | Handover for Voice over GERAN PS and CS | 430d | 2000-11-06 A | 2002-06-28 A | 100% | 2000-11-06 | 2002-06-28 | 430d | finish no earlier than 2002-06-28 | GP; R3 | 6880h | 6880h | Rel-5 | Paolo |  |  |  |  |
| 8272 | 109.3.4 | RTP payload | 430d | 2000-11-06 A | 2002-06-28 A | 100% | 2000-11-06 | 2002-06-28 | 430d | finish no earlier than 2002-06-28 | GP; R3 | 6880h | 6880h | Rel-5 | Paolo |  |  |  |  |
| 8273 | 109.3.5 | Codec renegotiation concept | 365d | 2000-11-06 A | 2002-03-29 A | 100% | 2000-11-06 | 2002-03-29 | 365d | finish no earlier than 2002-03-29 | GP; R3 | 5840h | 5840h | Rel-5 | Paolo |  |  |  |  |
| 8274 | 109.3.6 | LA | 115d | 2000-11-06 A | 2001-04-13 A | 100% | 2000-11-06 | 2001-04-13 | 115d | finish no earlier than 2001-04-13 | GP | 920h | 920h | Rel-5 | Paolo |  |  |  |  |

Notes:
- 8251: -
- 8252: -
- 8253: -
- 8254: -
- 8255: AWS, Nokia, Ericsson, Nortel, Siemens, Vodafone
- 8256: -
- 8257: -
- 8258: -
- 8259: -
- 8260: -
- 8261: -
- 8262: -
- 8263: -
- 8264: -
- 8265: -
- 8266: -
- 8267: -
- 8268: -
- 8269: -
- 8270: -
- 8271: -
- 8272: -
- 8273: -
- 8274: -

| ID | WBS | Task | Duration | Start | Finish | Complete | Baseline start | Baseline finish | Baseline duration | Constraint | Resources | Work | Actual work | Release | MCC resp | TSG stopped | Acronym | WI rapporteur name | WI rapporteur e-mail | Acronym_3GU_Export | Impacted TSs and TRs |
| --- | --- | --- | --- | --- | --- | --- | --- | --- | --- | --- | --- | --- | --- | --- | --- | --- | --- | --- | --- | --- | --- |
| 8275 | 109.4 | **Deleted - GERAN MS Conformance test for GERAN interface evolution** | 660d | 2001-06-11 A | 2003-12-19 A | 100% | 2001-06-11 | 2003-12-19 | 660d |  | GP | 10560h | 10560h | Rel-5 | Paolo | GP-17 |  |  |  |  |  |
| 8276 | 109.4.1 | Deleted - MS test for GERAN interface evolution | 660d | 2001-06-11 A | 2003-12-19 A | 100% | 2001-06-11 | 2003-12-19 | 660d | finish no earlier than 2003-12-19 | GP | 5280h | 5280h | Rel-5 | Paolo | GP-17 |  |  |  |  |  |
| 8277 | 109.5 | **GERAN BSS Conformance test for GERAN interface evolution** | 922d | 2000-06-08 A | 2003-12-19 A | 100% | 2000-06-08 | 2003-12-19 | 922d |  | GP | 14752h | 14752h | Rel-5 | Paolo |  |  |  |  |  |  |
| 8278 | 109.5.1 | Deleted - BSS test | 922d | 2000-06-08 A | 2003-12-19 A | 100% | 2000-06-08 | 2003-12-19 | 922d | finish no earlier than 2003-12-19 | GP | 7376h | 7376h | Rel-5 | Paolo | GP-17 |  |  |  |  |  |
| 8279 | 110 | **GERAN support for IMS** | 690d | 2000-05-01 A | 2002-12-20 A | 100% | 2000-05-01 | 2002-12-20 | 690d |  | GP | 83939.6h | 83939.6h | Rel-5 | Paolo |  | GERIMS | Nokia | Shkumbin Hamiti | GERIMS |  |
| 8280 | 110.1 | **GERAN Header adaptation** | 690d | 2000-05-01 A | 2002-12-20 A | 100% | 2000-05-01 | 2002-12-20 | 690d |  | GP; S2; RP | 40011.6h | 40011.6h | Rel-5 | Paolo |  | GERIMS-HEADAPT | Nokia | Shkumbin Hamiti | GERIMS-HEADAPT |  |
| 8281 | 110.1.1 | Definition of compression and removal modes for PDCP protocol | 29.15d | 2000-07-24 A | 2000-09-01 A | 100% | 2000-07-24 | 2000-09-01 | 29.15d | finish no earlier than 2000-09-01 | GP; S2; RP | 699.6h | 699.6h | Rel-5 | Paolo |  |  |  |  |  |  |
| 8282 | 110.1.2 | Conceptual description in stage 2 | 393d | 2000-05-01 A | 2001-10-31 A | 100% | 2000-05-01 | 2001-10-31 | 393d | finish no earlier than 2001-10-31 | GP; S2; RP | 9432h | 9432h | Rel-5 | Paolo |  |  |  |  |  |  |
| 8283 | 110.1.3 | Necessary changes on stage 3 regarding header removal | 555d | 2000-11-06 A | 2002-12-20 A | 100% | 2000-11-06 | 2002-12-20 | 555d | finish no earlier than 2002-12-20 | GP; S2; RP | 13320h | 13320h | Rel-5 | Paolo |  |  |  |  |  |  |
| 8284 | 110.2 | **Deleted - GERAN Radio access bearer design for IMS** | 430d | 2000-11-06 A | 2002-06-28 A | 100% | 2000-11-06 | 2002-06-28 | 430d |  | GP; S2; RP | 29520h | 29520h | Rel-5 | Paolo | GP-10 | GERIMS-RABDES | Nokia | Shkumbin Hamiti | GERIMS-RABDES |  |
| 8285 | 110.2.1 | **Deleted - MuM control signalling for conversational multimedia services** | 430d | 2000-11-06 A | 2002-06-28 A | 100% | 2000-11-06 | 2002-06-28 | 430d |  | GP; S2; RP | 19200h | 19200h | Rel-5 | Paolo | GP-10 |  |  |  |  |  |
| 8286 | 110.2.1.1 | Deleted - Identification of requirements for MuM control signalling for conversational multimedia services | 330d | 2000-11-06 A | 2002-02-08 A | 100% | 2000-11-06 | 2002-02-08 | 330d | finish no earlier than 2002-02-08 | GP; S2; RP | 7920h | 7920h | Rel-5 | Paolo | GP-08 |  |  |  |  |  |
| 8287 | 110.2.1.2 | Deleted - Necessary modifications due to SIP | 40d | 2002-05-06 A | 2002-06-28 A | 100% | 2002-05-06 | 2002-06-28 | 40d | finish no earlier than 2002-06-28 | GP; S2; RP | 960h | 960h | Rel-5 | Paolo | GP-10 |  |  |  |  |  |
| 8288 | 110.3 | **Deleted - GERAN MS Conformance test for support of IMS** | 400d | 2001-06-11 A | 2002-12-20 A | 100% | 2001-06-11 | 2002-12-20 | 400d |  | GP | 6400h | 6400h | Rel-5 | Paolo | GP-12 | GERIMS-MSconf | Nokia | Shkumbin Hamiti | GERIMS-MSconf |  |
| 8289 | 110.3.1 | Deleted - MS test for support of IMS | 400d | 2001-06-11 A | 2002-12-20 A | 100% | 2001-06-11 | 2002-12-20 | 400d | finish no earlier than 2002-12-20 | G4 | 3200h | 3200h | Rel-5 | Paolo | GP-12 |  |  |  |  |  |
| 8290 | 110.4 | Deleted - GERAN BTS Conformance test for support of IMS | 400d | 2001-06-11 A | 2002-12-20 A | 100% | 2001-06-11 | 2002-12-20 | 400d |  | GP | 3200h | 3200h | Rel-5 | Paolo | GP-12 | GERIMS-BTSconf | Nokia | Shkumbin Hamiti | GERIMS-BTSconf |  |
| 8291 | 2490 | MS Conformance Testing of Dual Transfer Mode | 65d? | 2002-11-11 A | 2003-02-07 A | 100% | 2002-11-11 | 2003-02-07 | 65d? | finish no earlier than 2003-02-07 | G4; G5 | 1040h | 1040h | Rel-5 | Paolo |  | MSCTDTM | Vodafone | Dave Fox | MSCTDTM |  |
| 8292 | 2491 | **Handling of early Ues** | 911d? | 2000-01-03 A | 2003-06-27 A | 100% | 2000-01-03 | 2003-06-27 | 911d? |  | S2 | 4488h | 4488h | Rel-5 | Maurice |  | LATE_UE |  |  | LATE_UE |  |
| 8293 | 2491.1 | Feasibility Study on Handling of early Ues | 50d? | 2002-10-07 A | 2002-12-13 A | 100% | 2002-10-07 | 2002-12-13 | 50d? | finish no earlier than 2002-12-13 | S2 | 400h | 400h | Rel-5 | Maurice |  |  |  |  |  |  |
| 8294 | 2491.2 | Stage 2 for Handling of early Ues | 125d? | 2003-01-06 A | 2003-06-27 A | 100% | 2003-01-06 | 2003-06-27 | 125d? | start no earlier than 2003-01-06 | S2 | 1000h | 1000h | Rel-5 | Maurice |  |  |  |  |  |  |
| 8295 | 2491.3 | FS for the Early Mobile Handling in UTRAN | 195d | 2002-09-09 A | 2003-06-06 A | 100% | 2002-09-09 | 2003-06-06 | 195d | finish no earlier than 2003-06-06 | R2 | 1560h | 1560h | Rel-5 | Yong-Jun |  | FSEarlyUE | Vodafone | alan.law@vodafone.com | FSEarlyUE |  |
| 8296 | 2491.4 | Note: Stage 3 RAN part not shown | 1d | 2000-01-03 A | 2000-01-03 A | 100% | 2000-01-03 | 2000-01-03 | 1d |  | RP | 8h | 8h | Rel-5 |  |  |  |  |  |  |  |
| 8297 | 2492 | --- RELEASE 4 --- | 326d? | 2000-01-03 A | 2001-03-30 A | 100% | 2000-01-03 | 2001-03-30 | 326d? |  | NP; GP; RP; SP; TP | 13040h | 13040h | Rel-4 | All |  |  |  |  |  |  |
| 8298 | 15 | **Miscellaneous UE Conformance Testing Activities** | 958d | 2001-04-02 A | 2004-12-01 A | 100% | 2001-04-02 | 2004-12-01 | 958d |  | T1 | 36360h | 36360h | Rel-4 | Ingbert |  | MISTST1 |  |  | MISTST1 |  |
| 8299 | 15.1 | Optimization of Test Time, RF Aspects (FDD) | 508d | 2001-09-24 A | 2003-09-03 A | 100% | 2001-09-24 | 2003-09-03 | 508d | finish no earlier than 2003-09-03 | T1 | 4064h | 4064h | Rel-4 | Ingbert |  | MISTST1-OpFDD |  |  | MISTST1-OpFDD | 34.121 |
| 8300 | 15.2 | Optimization of Test Time, RF Aspects (TDD) | 508d | 2001-09-24 A | 2003-09-03 A | 100% | 2001-09-24 | 2003-09-03 | 508d | finish no earlier than 2003-09-03 | T1 | 4064h | 4064h | Rel-4 | Ingbert |  | MISTST1-OpTDD |  |  | MISTST1-OpTDD | 34.122 |
| 8301 | 15.3 | Extensions to R99 Test cases | 139.4w | 2001-04-02 A | 2003-12-02 A | 100% | 2001-04-02 | 2003-12-02 | 139.4w | finish no earlier than 2003-12-02 | T1 | 5576h | 5576h | Rel-4 | Ingbert |  | MISTST1-Ext |  |  | MISTST1-Ext | 34.123 p 1.2 |
| 8302 | 15.4 | Extension to R99 Test cases - TTCN | 439d | 2002-06-28 A | 2004-03-03 A | 100% | 2002-06-28 | 2004-03-03 | 439d | finish no earlier than 2004-03-03 | T1 | 3512h | 3512h | Rel-4 | Ingbert |  |  |  |  |  |  |
| 8303 | 15.5 | Creation of R99 TCs for TDD - prose | 719d | 2001-10-01 A | 2004-07-01 A | 100% | 2001-10-01 | 2004-07-01 | 719d | finish no earlier than 2004-07-01 | T1 | 5752h | 5752h | Rel-4 | Ingbert |  | MISTST1-TDD |  |  | MISTST1-TDD | 34.123-1 |
| 8304 | 15.6 | Deleted - Creation of R99 TCs for TDD - TTCN | 587d | 2002-09-03 A | 2004-12-01 A | 100% | 2002-09-03 | 2004-12-01 | 587d | finish no earlier than 2004-12-01 | T1 | 4696h | 4696h | Rel-4 | Ingbert | TP-26 |  |  |  |  |  |
| 8305 | 15.7 | Deleted - Review all other work items for impact on new or exiting 34 series specs. | 25.8w | 2002-07-02 A | 2002-12-27 A | 100% | 2002-07-02 | 2002-12-27 | 25.8w | finish no earlier than 2002-12-27 | T1 | 1032h | 1032h | Rel-4 | Ingbert | TP-18 |  |  |  |  | 34.121.122.123.125 |

Notes:
- 8275: Not started. Marked as stopped 12/2008
- 8276: Not started. Marked as stopped 12/2008
- 8277: Not started. Marked as stopped 12/2008
- 8278: Not started. Marked as stopped 12/2008
- 8279: AWS, Nokia, Ericsson, Nortel, Siemens, Motorola
- 8280: AWS, Nokia, Ericsson, Nortel, Siemens, Motorola
- 8281: -
- 8282: -
- 8283: -
- 8284: TERMINATED - NOT STANDARDIZED. Marked as stopped 12/2008
- 8285: TERMINATED - NOT STANDARDIZED. Marked as stopped 12/2008
- 8286: TERMINATED - NOT STANDARDIZED
- 8287: TERMINATED - NOT STANDARDIZED
- 8288: TERMINATED - NOT STANDARDIZED. Marked as stopped 12/2008
- 8289: TERMINATED - NOT STANDARDIZED. Marked as stopped 12/2008
- 8290: TERMINATED - NOT STANDARDIZED. Marked as stopped 12/2008
- 8291: Needed to complete DTM (R99)
- 8292: -
- 8293: -
- 8294: -
- 8295: -
- 8296: -
- 8297: -
- 8298: -
- 8299: It is believed that the current R99 test spec. can be optimised for faster overall test times. Marked as stopped 12/2008 (was 70% complete)
- 8300: It is believed that the current R99 test spec. can be optimised for faster overall test times
- 8301: Further test coverage of the R99 specification to cover supplementry services. Marked as stopped 12/2008 (was 70% complete)
- 8302: Marked as closed 12/2008 (was marked 50% complete)
- 8303: Marked as closed 12/2008 (was marked 50% complete)
- 8304: Marked as stopped 12/2008
- 8305: Marked as stopped 12/2008

| ID | WBS | Task | Duration | Start | Finish | Predecessors | Complete | Baseline start | Baseline finish | Baseline duration | Constraint | Resources | Work | Actual work | Acronym | Release | MCC resp | Acronym_3GU_Export | Impacted TSs and TRs | WI rapporteur name | WI rapporteur e-mail |
| --- | --- | --- | --- | --- | --- | --- | --- | --- | --- | --- | --- | --- | --- | --- | --- | --- | --- | --- | --- | --- | --- |
| 8306 | 46 | **Real Time Facsimile** | 89d | 2000-02-22 A | 2000-06-23 A |  | 100% | 2000-02-22 | 2000-06-23 | 89d |  | S1 | 4376h | 4376h | FAX-RT | Rel-4 | Alain | FAX-RT |  |  |  |
| 8307 | 46.1 | **Real Time Fax** | 89d | 2000-02-22 A | 2000-06-23 A |  | 100% | 2000-02-22 | 2000-06-23 | 89d |  | S2 | 3664h | 3664h |  | Rel-4 | Maurice |  |  |  |  |
| 8308 | 46.1.1 | Terminal capabilities, AT commands | 89d | 2000-02-22 A | 2000-06-23 A |  | 100% | 2000-02-22 | 2000-06-23 | 89d | finish no earlier than 2000-06-23 | T2 | 712h | 712h |  | Rel-4 |  |  | 21.904; 27.007 |  |  |
| 8309 | 46.1.2 | Signalling aspects (e.g. ICM) | 89d | 2000-02-22 A | 2000-06-23 A |  | 100% | 2000-02-22 | 2000-06-23 | 89d | start no earlier than 2000-02-22 | N1 | 712h | 712h |  | Rel-4 | Frederic |  |  |  |  |
| 8310 | 46.1.3 | Service provision | 89d | 2000-02-22 A | 2000-06-23 A |  | 100% | 2000-02-22 | 2000-06-23 | 89d | finish no earlier than 2000-06-23 | N3 | 712h | 712h |  | Rel-4 | Gwiho |  | 23.146 |  |  |
| 8311 | 46.1.4 | Review whether service/stage 1 aspects need to be aligned | 51d | 2000-04-14 A | 2000-06-23 A |  | 100% | 2000-04-14 | 2000-06-23 | 51d | finish no earlier than 2000-12-14 | S1 | 408h | 408h |  | Rel-4 | Alain |  |  |  |  |
| 8312 | 46.1.5 | Review whether architecture/stage 2 aspects need to be aligned | 51d | 2000-04-14 A | 2000-06-23 A |  | 100% | 2000-04-14 | 2000-06-23 | 51d | finish no earlier than 2000-12-14 | S2 | 408h | 408h |  | Rel-4 | Maurice |  |  |  |  |
| 8313 | 47 | Transparent End-to-End PS mobile streaming application | 253d | 2000-04-03 A | 2001-03-21 A |  | 100% | 2000-04-03 | 2001-03-21 | 253d | finish no earlier than 2000-12-29 | S4 | 2024h | 2024h | PSTREAM | Rel-4 | Paolo | PSTREAM | 26.233; 26.234 |  |  |
| 8314 | 48 | **Multimedia Messaging** | 277d | 2000-02-22 A | 2001-03-14 A |  | 100% | 2000-02-22 | 2001-03-14 | 277d |  | T2; S1 | 14424h | 14424h | MMS4 | Rel-4 | Kimmo | MMS, Rel-4 | 22.140; 23.140 | Siemens | Josef.Laumen@SAL.SIEMENS.DE |
| 8315 | 48.1 | Definition of service requirements for Multimedia Messaging | 72d | 2000-02-22 A | 2000-05-31 A |  | 100% | 2000-02-22 | 2000-05-31 | 72d | start no earlier than 2000-02-22 | S1 | 576h | 576h |  | Rel-4 | Alain |  |  |  |  |
| 8316 | 48.2 | Review of definition of service requirements | 205d | 2000-06-01 A | 2001-03-14 A | 8315 | 100% | 2000-06-01 | 2001-03-14 | 205d | finish no earlier than 2000-09-08 | T2 | 1640h | 1640h |  | Rel-4 | Kimmo |  | 22.140; 23.140 | Siemens |  |
| 8317 | 48.3 | **Technical Realisation** | 243d | 2000-04-10 A | 2001-03-14 A |  | 100% | 2000-04-10 | 2001-03-14 | 243d |  | T2 | 7776h | 7776h |  | Rel-4 | Kimmo |  | 22.140; 23.140 | Siemens | Josef.Laumen@SAL.SIEMENS.DE |
| 8318 | 48.3.1 | Review of definition of reference Achitecture model | 243d | 2000-04-10 A | 2001-03-14 A |  | 100% | 2000-04-10 | 2001-03-14 | 243d | finish no earlier than 2001-03-14 | T2 | 1944h | 1944h |  | Rel-4 | Kimmo |  | 22.140; 23.140 | Siemens | Josef.Laumen@SAL.SIEMENS.DE |
| 8319 | 48.3.2 | Fulfill Requirements of Stage 1 | 243d | 2000-04-10 A | 2001-03-14 A |  | 100% | 2000-04-10 | 2001-03-14 | 243d | finish no earlier than 2001-03-14 | T2 | 1944h | 1944h |  | Rel-4 | Kimmo |  | 22.140; 23.140 | Siemens | Josef.Laumen@SAL.SIEMENS.DE |
| 8320 | 48.3.3 | Definition of MMS primitives in Stage 2 | 243d | 2000-04-10 A | 2001-03-14 A |  | 100% | 2000-04-10 | 2001-03-14 | 243d | finish no earlier than 2001-03-14 | T2 | 1944h | 1944h |  | Rel-4 | Kimmo |  | 22.140; 23.140 | Siemens | Josef.Laumen@SAL.SIEMENS.DE |
| 8321 | 49 | **Transcoder-Free Operation** | 326d | 2000-01-03 A | 2001-03-30 A |  | 100% | 2000-01-03 | 2001-03-30 | 326d |  | N4; S2; N1 | 18272h | 18272h | TrFO | Rel-4 | Kimmo | TrFO |  |  |  |
| 8322 | 49.1 | **Out-of-Band Transcoder Control solution** | 326d | 2000-01-03 A | 2001-03-30 A |  | 100% | 2000-01-03 | 2001-03-30 | 326d |  | N4 | 8448h | 8448h | TrFO-OoBTC | Rel-4 | Kimmo | TrFO-OoBTC |  | NEC | Toshiyuki Tamura (tamurato@aj.jp.nec.com) |
| 8323 | 49.1.1 | implementation in UTRAN | 145d | 2000-09-11 A | 2001-03-30 A |  | 100% | 2000-09-11 | 2001-03-30 | 145d | finish no earlier than 2001-03-30 | R3 | 1160h | 1160h | TrFO-OoBTC-UTRAN | Rel-4 | Juha | TrFO-OoBTC-UTRAN | 25.401; 25.410; 25.413; 25.415; 23.153 | Siemens | Alexander Vesely |
| 8324 | 49.1.2 | Impact on architecture, Principles and Terminology | 211d | 2000-01-03 A | 2000-10-20 A |  | 100% | 2000-01-03 | 2000-10-20 | 211d | finish no earlier than 2000-10-20 | S2 | 1680h | 1680h |  | Rel-4 | Maurice |  |  |  |  |
| 8325 | 49.1.3 | Codec Negotiation between UE and MSC | 125d | 2000-08-14 A | 2001-02-02 A |  | 100% | 2000-08-14 | 2001-02-02 | 125d | finish no earlier than 2001-02-02 | N1 | 1000h | 1000h |  | Rel-4 | Frederic |  | 24.008; 23.009; 23.108; (29.002) | Motorola | Andrew Howell |
| 8326 | 49.1.4 | Codec Negotiation inter MSC | 125d | 2000-07-03 A | 2000-12-22 A |  | 100% | 2000-07-03 | 2000-12-22 | 125d | finish no earlier than 2000-12-22 | N4 | 1000h | 1000h |  | Rel-4 | Kimmo |  |  |  |  |
| 8327 | 49.1.5 | Bearer establishment inter MSC | 125d | 2000-07-03 A | 2000-12-22 A |  | 100% | 2000-07-03 | 2000-12-22 | 125d | finish no earlier than 2000-12-22 | N4 | 1000h | 1000h |  | Rel-4 | Kimmo |  | 23.153 |  |  |
| 8328 | 49.2 | **Speech Transcoder: Location and Control at the UMTS Core Network Border** | 125d | 2000-04-10 A | 2000-09-29 A |  | 100% | 2000-04-10 | 2000-09-29 | 125d |  | S2 | 2000h | 2000h | TrFO-STLC | Rel-4 | Maurice | TrFO-STLC |  |  |  |
| 8329 | 49.2.1 | Transcoder at Edge | 125d | 2000-04-10 A | 2000-09-29 A |  | 100% | 2000-04-10 | 2000-09-29 | 125d | finish no earlier than 2000-09-29 | NP | 1000h | 1000h |  | Rel-4 | Kimmo |  |  |  |  |

Notes:
- 8306: -
- 8307: postponed from R99 to R00, SP-000169
- 8308: -
- 8309: -
- 8310: -
- 8311: -
- 8312: -
- 8313: -
- 8314: Acronym changed from "MMS, Rel-4"
- 8315: -
- 8316: -
- 8317: -
- 8318: -
- 8319: e.g. minimum set of media formats, media format conversion, personalization of MMS.
- 8320: -
- 8321: Lead given to CN4 from CN
- 8322: -
- 8323: moved according to NP-000575
- 8324: e.g. study cascading TrFO/TFO/TrFO
- 8325: the link to NP-000085has been deleted because refering to a R99 status sheet
- 8326: Bearer establishment inter MSC. TS 23.153 R99 part complete. capabilities moved to annex + list of open issues
- 8327: Bearer establishment inter MSC. TS 23.153 R99 part complete. capabilities moved to annex.
- 8328: WI description and Tdoc S2-99352
- 8329: WI description and Tdoc S2-99352

| ID | WBS | Task | Duration | Start | Finish | Complete | Baseline start | Baseline finish | Baseline duration | Constraint | Resources | Work | Actual work | Acronym | Release | MCC resp | Acronym_3GU_Export | WI rapporteur name | WI rapporteur e-mail |
| --- | --- | --- | --- | --- | --- | --- | --- | --- | --- | --- | --- | --- | --- | --- | --- | --- | --- | --- | --- |
| 8330 | 50 | **GERAN improvements 1 (Gb over IP)** | 225d | 2000-05-09 A | 2001-03-19 A | 100% | 2000-05-09 | 2001-03-19 | 225d |  | GP | 6472h | 6472h | GEIMP1 | Rel-4 | Paolo | GEIMP1 |  |  |
| 8331 | 50.1 | **Gb over IP (Ip-fication of Gb)** | 225d | 2000-05-09 A | 2001-03-19 A | 100% | 2000-05-09 | 2001-03-19 | 225d |  | GP | 4672h | 4672h | GbIP | Rel-4 | Paolo | GbIP |  |  |
| 8332 | 50.1.1 | Concept of Gb over IP (Ip-fication of Gb) | 134d | 2000-05-09 A | 2000-11-10 A | 100% | 2000-05-09 | 2000-11-10 | 134d |  | GP | 1072h | 1072h |  | Rel-4 | Paolo |  |  |  |
| 8333 | 50.1.2 | Changes to 08.16, 08.18 | 225d | 2000-05-09 A | 2001-03-19 A | 100% | 2000-05-09 | 2001-03-19 | 225d |  | GP | 1800h | 1800h |  | Rel-4 | Paolo |  |  |  |
| 8334 | 51 | **GERAN improvements 2 (NACC)** | 677d | 2000-11-06 A | 2003-06-10 A | 100% | 2000-11-06 | 2003-06-10 | 677d |  | GP | 22408h | 22408h | GEIMP2 | Rel-4 | Paolo | GEIMP2 |  |  |
| 8335 | 51.1 | **Gb enhancements** | 155d | 2000-11-06 A | 2001-06-08 A | 100% | 2000-11-06 | 2001-06-08 | 155d |  | GP | 7440h | 7440h | Gben | Rel-4 | Paolo | Gben |  |  |
| 8336 | 51.1.1 | **Intra BSC NACC (Network Assisted Cell Change)** | 155d | 2000-11-06 A | 2001-06-08 A | 100% | 2000-11-06 | 2001-06-08 | 155d |  | GP | 6200h | 6200h |  | Rel-4 | Paolo |  |  |  |
| 8337 | 51.1.1.1 | Concept | 155d | 2000-11-06 A | 2001-06-08 A | 100% | 2000-11-06 | 2001-06-08 | 155d | finish no earlier than 2001-06-08 | GP | 1240h | 1240h |  | Rel-4 | Paolo |  |  |  |
| 8338 | 51.1.1.2 | Changes in 03.64 | 155d | 2000-11-06 A | 2001-06-08 A | 100% | 2000-11-06 | 2001-06-08 | 155d | finish no earlier than 2001-06-08 | GP | 1240h | 1240h |  | Rel-4 | Paolo |  |  |  |
| 8339 | 51.1.1.3 | Changes in 04.60 | 155d | 2000-11-06 A | 2001-06-08 A | 100% | 2000-11-06 | 2001-06-08 | 155d | finish no earlier than 2001-06-08 | GP | 1240h | 1240h |  | Rel-4 | Paolo |  |  |  |
| 8340 | 51.1.1.4 | Changes in 44.008 | 155d | 2000-11-06 A | 2001-06-08 A | 100% | 2000-11-06 | 2001-06-08 | 155d | finish no earlier than 2001-06-08 | GP | 1240h | 1240h |  | Rel-4 | Paolo |  |  |  |
| 8341 | 51.3 | **MS conformance test for Intra BSC NACC** | 398d | 2001-11-30 A | 2003-06-10 A | 100% | 2001-11-30 | 2003-06-10 | 398d |  | GP | 9552h | 9552h | GEIMP2-Msconf | Rel-4 | Paolo | GEIMP2-Msconf |  |  |
| 8342 | 51.3.1 | Changes in 51.010 | 398d | 2001-11-30 A | 2003-06-10 A | 100% | 2001-11-30 | 2003-06-10 | 398d | finish no earlier than 2003-12-19 | G5; G4 | 6368h | 6368h |  | Rel-4 | Paolo |  |  |  |
| 8343 | 52 | **GERAN improvements 4 (Delayed TBF)** | 105d | 2001-01-15 A | 2001-06-08 A | 100% | 2001-01-15 | 2001-06-08 | 105d |  | GP | 3960h | 3960h | GEIMP4 | Rel-4 | Paolo | GEIMP4 |  |  |
| 8344 | 52.1 | **Gb enhancements 2** | 105d | 2001-01-15 A | 2001-06-08 A | 100% | 2001-01-15 | 2001-06-08 | 105d |  | GP | 3120h | 3120h | GEIMP4-Gben2 | Rel-4 | Paolo | GEIMP4-Gben2 |  |  |
| 8345 | 52.1.1 | Stage 2 for Gb enhancements 2 | 105d | 2001-01-15 A | 2001-06-08 A | 100% | 2001-01-15 | 2001-06-08 | 105d | finish no earlier than 2001-06-08 | GP | 840h | 840h |  | Rel-4 | Paolo |  |  |  |
| 8346 | 52.1.2 | **Stage 3 (changes in 44.060)** | 60d | 2001-01-15 A | 2001-04-06 A | 100% | 2001-01-15 | 2001-04-06 | 60d |  | G2 | 1440h | 1440h |  | Rel-4 | Gert |  |  |  |
| 8347 | 52.1.2.1 | Definition of enhanced countdown procedure | 60d | 2001-01-15 A | 2001-04-06 A | 100% | 2001-01-15 | 2001-04-06 | 60d | finish no earlier than 2001-04-06 | G2 | 480h | 480h |  | Rel-4 | Gert |  |  |  |
| 8348 | 52.1.2.2 | Definition of enhanced TBF release procedure | 60d | 2001-01-15 A | 2001-04-06 A | 100% | 2001-01-15 | 2001-04-06 | 60d | finish no earlier than 2001-04-06 | G2 | 480h | 480h |  | Rel-4 | Gert |  |  |  |
| 8349 | 52.1.2.3 | Definition of USF=FREE type polling mechanism on PDCH | 60d | 2001-01-15 A | 2001-04-06 A | 100% | 2001-01-15 | 2001-04-06 | 60d | finish no earlier than 2001-04-06 | G2 | 480h | 480h |  | Rel-4 | Gert |  |  |  |
| 8350 | 53 | **Low Chip Rate TDD option** | 880d | 2000-07-19 A | 2003-12-02 A | 100% | 2000-07-19 | 2003-12-02 | 880d |  | R1 | 27488h | 27488h | LCRTDD | Rel-4 | Patrick | LCRTDD | CWTS | G. Yang |
| 8351 | 53.1 | Physical layer for Low Chip Rate TDD option | 183d | 2000-07-19 A | 2001-03-30 A | 100% | 2000-07-19 | 2001-03-30 | 183d | finish no earlier than 2001-03-30 | R1 | 1464h | 1464h | LCRTDD-Phys | Rel-4 | Patrick | LCRTDD-Phys | CWTS | G. Yang |
| 8352 | 53.2 | Layer 2 and layer 3 protocol aspects | 183d | 2000-07-19 A | 2001-03-30 A | 100% | 2000-07-19 | 2001-03-30 | 183d | finish no earlier than 2001-03-30 | R2 | 1464h | 1464h | LCRTDD-L23 | Rel-4 | Yong-Jun | LCRTDD-L23 | CWTS | Y. Liu |
| 8353 | 53.3 | RF radio transmission/reception, system performance requirements and conformance testing | 165d | 2000-08-14 A | 2001-03-30 A | 100% | 2000-08-14 | 2001-03-30 | 165d | finish no earlier than 2001-03-30 | R4 | 1320h | 1320h | LCRTDD-RF | Rel-4 | Issam | LCRTDD-RF | CWTS | D. Zhang |
| 8354 | 53.4 | UE radio access capability | 165d | 2000-08-14 A | 2001-03-30 A | 100% | 2000-08-14 | 2001-03-30 | 165d | finish no earlier than 2001-03-30 | R2 | 1320h | 1320h | LCRTDD-UErac | Rel-4 | Yong-Jun | LCRTDD-UErac | CWTS | Y. Liu |
| 8355 | 53.5 | Iub/Iur protocol aspects - for Low Chip Rate TDD option | 165d | 2000-08-14 A | 2001-03-30 A | 100% | 2000-08-14 | 2001-03-30 | 165d | finish no earlier than 2001-03-30 | R3 | 1320h | 1320h | LCRTDD-IubIur | Rel-4 | Juha | LCRTDD-IubIur | CWTS | Y. Liu |

Notes:
- 8330: -
- 8331: -
- 8332: -
- 8333: -
- 8334: -
- 8335: -
- 8336: -
- 8337: -
- 8338: -
- 8339: -
- 8340: -
- 8341: -
- 8342: az 05/08: duplicated UID_50099 => 50299. Marked as closed 12/2008 (was marked 50% complete)
- 8343: -
- 8344: -
- 8345: -
- 8346: -
- 8347: -
- 8348: -
- 8349: -
- 8350: -
- 8351: -
- 8352: -
- 8353: -
- 8354: -
- 8355: -

| ID | WBS | Task | Duration | Start | Finish | Predecessors | Complete | Baseline start | Baseline finish | Baseline duration | Constraint | Resources | Work | Actual work | Release | MCC resp | Impacted TSs and TRs | TSG stopped | Acronym | WI rapporteur name | WI rapporteur e-mail | Acronym_3GU_Export |
| --- | --- | --- | --- | --- | --- | --- | --- | --- | --- | --- | --- | --- | --- | --- | --- | --- | --- | --- | --- | --- | --- | --- |
| 8356 | 53.6 | **Low chiprate TDD interworking with GERAN** | 101d | 2000-09-01 A | 2001-01-19 A | 8355 | 100% | 2000-09-01 | 2001-01-19 | 101d |  | GP | 1616h | 1616h | Rel-4 | Paolo |  |  |  |  |  |  |
| 8357 | 53.6.1 | Handover and Cell Selection / Reselection to UTRA 1.28 Mcps TDD | 101d | 2000-09-01 A | 2001-01-19 A |  | 100% | 2000-09-01 | 2001-01-19 | 101d | finish no earlier than 2001-01-19 | GP | 808h | 808h | Rel-4 | Paolo |  |  |  |  |  |  |
| 8358 | 53.8 | **Conformance Test Aspects - Low Chip Rate TDD** | 577d | 2001-09-17 A | 2003-12-02 A | 8356 | 100% | 2001-09-17 | 2003-12-02 | 577d |  | T1 | 12088h | 12088h | Rel-4 | Ingbert |  |  |  |  |  |  |
| 8359 | 53.8.1 | Testing Layer 2 and layer 3 protocol aspects | 468d | 2001-09-17 A | 2003-07-02 A |  | 100% | 2001-09-17 | 2003-07-02 | 468d | finish no earlier than 2003-07-02 | T1 | 3744h | 3744h | Rel-4 | Ingbert | 34.123-1; 34.123-2 |  |  |  |  |  |
| 8360 | 53.8.2 | Deleted - Testing Layer 2 and layer 3 protocol aspects - TTCN | 261d | 2002-12-03 A | 2003-12-02 A |  | 100% | 2002-12-03 | 2003-12-02 | 261d | finish no earlier than 2003-12-02 | T1 | 2088h | 2088h | Rel-4 | Ingbert | 34.123-3 | TP-22 |  |  |  |  |
| 8361 | 53.8.3 | Testing RF Radio Transmission and Reception | 205d | 2001-09-17 A | 2002-06-28 A |  | 100% | 2001-09-17 | 2002-06-28 | 205d | finish no earlier than 2002-06-28 | T1 | 1640h | 1640h | Rel-4 | Ingbert |  |  |  |  |  |  |
| 8362 | 54 | **Enable bearer independent CS architecture** | 566d | 2000-01-03 A | 2002-03-01 A |  | 100% | 2000-01-03 | 2002-03-01 | 566d |  | S2; N3; N4 | 28008h | 28008h | Rel-4 | Maurice |  |  | CSSPLIT | Siemens | Alexander Milinski | CSSPLIT |
| 8363 | 54.1 | **Enable bearer-independent call control** | 425d | 2000-01-03 A | 2001-08-16 A |  | 100% | 2000-01-03 | 2001-08-16 | 425d |  | N4 | 12344h | 12344h | Rel-4 | Kimmo |  |  |  | Ericsson | Heinz-Peter.Keutmann@eed.ericsson.se |  |
| 8364 | 54.1.1 | Architecture and Stage 2 description | 181d | 2000-01-03 A | 2000-09-08 A |  | 100% | 2000-01-03 | 2000-09-08 | 181d | finish no earlier than 2000-09-08 | S2 | 1440h | 1440h | Rel-4 | Maurice | 23.002 |  |  |  |  |  |
| 8365 | 54.1.2 | Standardisation of protocols (control & user planes) over Nb interface | 64d | 2001-01-02 A | 2001-03-30 A |  | 100% | 2001-01-02 | 2001-03-30 | 64d | finish no earlier than 2001-03-30 | N3 | 512h | 512h | Rel-4 | Gwiho |  |  |  |  |  |  |
| 8366 | 54.1.3 | Standardisation of protocols over reference points between MSC server and Gateway MSC server | 130d | 2000-09-25 A | 2001-03-23 A |  | 100% | 2000-09-25 | 2001-03-23 | 130d | finish no earlier than 2001-03-23 | N4 | 1040h | 1040h | Rel-4 | Kimmo |  |  |  |  |  |  |
| 8367 | 54.1.4 | Standardisation of detailed stage 2 description | 180d | 2000-07-17 A | 2001-03-23 A |  | 100% | 2000-07-17 | 2001-03-23 | 180d | finish no earlier than 2001-03-23 | N4 | 1440h | 1440h | Rel-4 | Kimmo |  |  |  |  |  |  |
| 8368 | 54.1.5 | **Bearer control between MSC server and MGW** | 250d | 2000-09-01 A | 2001-08-16 A |  | 100% | 2000-09-01 | 2001-08-16 | 250d |  | N4 | 4512h | 4512h | Rel-4 | Kimmo |  |  |  |  |  |  |
| 8369 | 54.1.5.1 | stage 3 - protocol issues | 250d | 2000-09-01 A | 2001-08-16 A |  | 100% | 2000-09-01 | 2001-08-16 | 250d | finish no earlier than 2001-08-16 | N4 | 2000h | 2000h | Rel-4 | Kimmo |  |  |  |  |  |  |
| 8370 | 54.1.5.2 | stage 3 - parameter value issues | 64d | 2001-01-02 A | 2001-03-30 A |  | 100% | 2001-01-02 | 2001-03-30 | 64d | finish no earlier than 2001-03-30 | N3 | 512h | 512h | Rel-4 | Gwiho |  |  |  |  |  |  |
| 8371 | 54.4 | Deleted - Conformance Test Aspects - Enable bearer independent CS architecture | 260d | 2001-03-05 A | 2002-03-01 A |  | 100% | 2001-03-05 | 2002-03-01 | 260d |  | T1 | 2080h | 2080h | Rel-4 | Ingbert |  | TP-15 | CSSPLIT-TEST |  |  | CSSPLIT-TEST |
| 8372 | 55 | **MExE enhancements Rel-4** | 511d | 2000-01-03 A | 2001-12-14 A |  | 100% | 2000-01-03 | 2001-12-14 | 511d |  | T2; S3 | 26912h | 26912h | Rel-4 | Kimmo |  |  | MEXE |  |  | MEXE |
| 8373 | 55.1 | **MExE Security Analysis Activity** | 474d | 2000-02-22 A | 2001-12-14 A |  | 100% | 2000-02-22 | 2001-12-14 | 474d |  | S3; T2 | 12256h | 12256h | Rel-4 | Mirko |  |  | MEXE-SEC | BT | Andrew.Myers@bt.com | MEXE-SEC |
| 8374 | 55.1.1 | Stage 3 for MExE Security | 370d | 2000-07-17 A | 2001-12-14 A |  | 100% | 2000-07-17 | 2001-12-14 | 370d | finish no earlier than 2001-12-14 | S3 | 2960h | 2960h | Rel-4 | Mirko | 21.133; 33.102 |  |  | BT | Andrew.Myers@bt.com |  |
| 8375 | 55.1.2 | Terminal aspects for MExE Security | 214d | 2000-02-22 A | 2000-12-15 A |  | 100% | 2000-02-22 | 2000-12-15 | 214d | finish no earlier than 2000-12-15 | T2 | 1712h | 1712h | Rel-4 |  | 23.057 |  |  | BT | Andrew.Myers@bt.com |  |
| 8376 | 55.2 | **MExE Rel-4 Improvements and Investigations** | 251d | 2000-01-03 A | 2000-12-15 A |  | 100% | 2000-01-03 | 2000-12-15 | 251d |  | T2 | 6480h | 6480h | Rel-4 | Kimmo | 22.057; 23.057 |  | MEXE-ENHANC | Motorola | Mark Cataldo | MEXE-ENHANC |
| 8377 | 55.2.1 | 3rd MExE classmark | 251d | 2000-01-03 A | 2000-12-15 A |  | 100% | 2000-01-03 | 2000-12-15 | 251d | finish no earlier than 2000-12-15 | T2 | 2000h | 2000h | Rel-4 | Kimmo | 22.057; 23.057 |  |  | Motorola | Mark Cataldo |  |
| 8378 | 55.2.2 | FS on Secure download mechanism and capabilities to support SDR concepts | 225d | 2000-02-07 A | 2000-12-15 A |  | 100% | 2000-02-07 | 2000-12-15 | 225d | finish no earlier than 2000-12-15 | T2 | 1800h | 1800h | Rel-4 | Kimmo | 22.057; 23.057 |  |  | Motorola | Mark Cataldo |  |
| 8379 | 55.2.3 | FS on Support of MP3/MPEG4 content | 225d | 2000-02-07 A | 2000-12-15 A |  | 100% | 2000-02-07 | 2000-12-15 | 225d | finish no earlier than 2000-12-15 | T2 | 1800h | 1800h | Rel-4 | Kimmo | 22.057; 23.057 |  |  | Motorola | Mark Cataldo |  |

Notes:
- 8356: -
- 8357: -
- 8358: -
- 8359: Marked as closed 12/2008 (was marked 60% complete)
- 8360: Marked as stopped 12/2008
- 8361: duration set to 6 months (was 0), finish date set
- 8362: -
- 8363: DAB 12.12.01 should be 100% hence closed
- 8364: R00 stage 2 at least 80 % complete in TSGS #8 21.-23.6.2000
- 8365: -
- 8366: -
- 8367: -
- 8368: -
- 8369: -
- 8370: -
- 8371: Marked as stopped 12/2008
- 8372: -
- 8373: SP#12 updated WID
- 8374: -
- 8375: -
- 8376: -
- 8377: Additional features for MExE R2000
- 8378: -
- 8379: -

| ID | WBS | Task | Duration | Start | Finish | Complete | Baseline start | Baseline finish | Baseline duration | Constraint | Resources | Work | Actual work | Acronym | Release | MCC resp | Acronym_3GU_Export | Impacted TSs and TRs | WI rapporteur name | WI rapporteur e-mail |
| --- | --- | --- | --- | --- | --- | --- | --- | --- | --- | --- | --- | --- | --- | --- | --- | --- | --- | --- | --- | --- |
| 8380 | 56 | **Tandem Free aspects for 3G and between 2G and 3G systems** | 344d | 2000-02-22 A | 2001-06-15 A | 100% | 2000-02-22 | 2001-06-15 | 344d |  | S4 | 9696h | 9696h | TFO | Rel-4 | Paolo | TFO |  |  |  |
| 8381 | 56.1 | **Tandem Free AMR** | 344d | 2000-02-22 A | 2001-06-15 A | 100% | 2000-02-22 | 2001-06-15 | 344d |  | S4 | 6944h | 6944h | TFO-AMR | Rel-4 | Paolo | TFO-AMR |  |  |  |
| 8382 | 56.1.1 | Specification of Tandem Free AMR | 284d | 2000-02-22 A | 2001-03-23 A | 100% | 2000-02-22 | 2001-03-23 | 284d | start no earlier than 2000-02-22 | S4 | 2272h | 2272h |  | Rel-4 | Paolo |  | 28.062 |  |  |
| 8383 | 56.1.2 | **Impact of Tandem Free AMR on:** | 115d | 2001-01-08 A | 2001-06-15 A | 100% | 2001-01-08 | 2001-06-15 | 115d |  | NP | 1920h | 1920h |  | Rel-4 | Kimmo |  |  |  |  |
| 8384 | 56.1.2.1 | CN | 60d | 2001-03-26 A | 2001-06-15 A | 100% | 2001-03-26 | 2001-06-15 | 60d | finish no earlier than 2001-06-15 | NP | 480h | 480h |  | Rel-4 | Kimmo |  |  |  |  |
| 8385 | 56.1.2.2 | GERAN | 65d | 2001-01-08 A | 2001-04-06 A | 100% | 2001-01-08 | 2001-04-06 | 65d | finish no earlier than 2001-04-06 | GP | 520h | 520h |  | Rel-4 | Paolo |  |  |  |  |
| 8386 | 57 | **Advanced Speech Call Items enhancements_Rel-4** | 334d | 2000-12-03 A | 2002-03-14 A | 100% | 2000-12-03 | 2002-03-14 | 334d |  | N1 | 5925.6h | 5925.6h | ASCI4 | Rel-4 | Frederic | ASCI, Rel-4 |  | Nortel | sonia.garapaty@nortelnetworks.com |
| 8387 | 57.1 | Stage 2 for Advanced Speech Call Items enhancements_Rel-4 (ASCI) | 326.7d | 2000-12-03 A | 2002-03-14 A | 100% | 2000-12-03 | 2002-03-14 | 326.7d | finish no earlier than 2002-03-14 | N4 | 2613.6h | 2613.6h |  | Rel-4 | Kimmo |  | 23.067; 24.067 | Sagem | Vivien Perlic |
| 8388 | 57.2 | Stages 2 and 3 on A interface | 80d | 2000-12-03 A | 2001-03-23 A | 100% | 2000-12-03 | 2001-03-23 | 80d | finish no earlier than 2001-03-23 | N1 | 640h | 640h |  | Rel-4 | Frederic |  | 44.068; 44.069; 24.008 | Nortel | sonia.garapaty@nortelnetworks.com |
| 8389 | 58 | **700 MHz spectrum support** | 776d | 2000-01-03 A | 2002-12-20 A | 100% | 2000-01-03 | 2002-12-20 | 776d |  | GP | 20016h | 20016h | 700SS | Rel-4 | Paolo | 700SS |  |  |  |
| 8390 | 58.1 | **GERAN support for the 700 MHz band** | 276d | 2000-01-03 A | 2001-01-19 A | 100% | 2000-01-03 | 2001-01-19 | 276d |  | GP | 8808h | 8808h |  | Rel-4 | Paolo |  |  |  |  |
| 8391 | 58.1.1 | Signalling support | 276d | 2000-01-03 A | 2001-01-19 A | 100% | 2000-01-03 | 2001-01-19 | 276d | finish no earlier than 2001-01-19 | GP | 2200h | 2200h |  | Rel-4 | Paolo |  |  |  |  |
| 8392 | 58.1.2 | Physical layer definitions - for GERAN support for the 700 MHz band | 276d | 2000-01-03 A | 2001-01-19 A | 100% | 2000-01-03 | 2001-01-19 | 276d | finish no earlier than 2001-01-19 | GP | 2200h | 2200h |  | Rel-4 | Paolo |  |  |  |  |
| 8393 | 58.1.3 | Receiver performance and RF budget | 276d | 2000-01-03 A | 2001-01-19 A | 100% | 2000-01-03 | 2001-01-19 | 276d | finish no earlier than 2001-01-19 | GP | 2200h | 2200h |  | Rel-4 | Paolo |  |  |  |  |
| 8394 | 58.2 | GERAN MS Conformance test for 700 MHz band | 175d | 2001-04-02 A | 2001-11-30 A | 100% | 2001-04-02 | 2001-11-30 | 175d |  | GP | 1400h | 1400h |  | Rel-4 | Paolo |  |  |  |  |
| 8395 | 58.3 | GERAN BTS Conformance test for 700 MHz band | 450d | 2001-04-02 A | 2002-12-20 A | 100% | 2001-04-02 | 2002-12-20 | 450d |  | GP | 3600h | 3600h |  | Rel-4 | Paolo |  |  |  |  |
| 8396 | 59 | Operator Determined Barring for Packet Oriented Services | 208d | 2000-06-01 A | 2001-03-19 A | 100% | 2000-06-01 | 2001-03-19 | 208d | finish no earlier than 2001-03-19 | NP | 1664h | 1664h | ODB | Rel-4 | Kimmo | ODB |  | NEC | Toshiyuki Tamura (tamurato@aj.jp.nec.com) |
| 8397 | 60 | **UMTS QoS Architecture for PS Domain** | 759d | 2000-01-03 A | 2002-11-27 A | 100% | 2000-01-03 | 2002-11-27 | 759d |  | S2; S5; R3; GP | 72848h | 72848h | QoSPS | Rel-4 | Maurice | QoSPS |  | Ericsson | Ina.widegren@era.ericsson.se |
| 8398 | 60.1 | Architecture | 153d | 2000-06-05 A | 2001-01-03 A | 100% | 2000-06-05 | 2001-01-03 | 153d | finish no earlier than 2001-01-03 | S2 | 1224h | 1224h |  | Rel-4 | Maurice |  | 23.107 |  |  |
| 8399 | 60.2 | Charging and OAM&P for QoS Management | 201d | 2001-09-21 A | 2002-06-28 A | 100% | 2001-09-21 | 2002-06-28 | 201d | finish no earlier than 2002-06-28 | S5 | 1608h | 1608h | QoSPS-OAM | Rel-4 | Mirko | QoSPS-OAM | 32-series |  |  |
| 8400 | 60.3 | **RAB Quality of Service (re)Negotiation over Iu** | 155d | 2000-08-21 A | 2001-03-23 A | 100% | 2000-08-21 | 2001-03-23 | 155d |  | R3 | 3648h | 3648h | QoSPS-MAPEND-RABQoS | Rel-4 | Juha | QoSPS-MAPEND-RABQoS | 25.413 | Ericsson | anders.molander@ericsson.com |
| 8401 | 60.3.1 | RAB Quality of Service Negotiation over Iu | 155d | 2000-08-21 A | 2001-03-23 A | 100% | 2000-08-21 | 2001-03-23 | 155d | finish no earlier than 2001-03-23 | R3 | 1240h | 1240h | QoSPS-MAPEND-RABQoS-Negot | Rel-4 | Juha | QoSPS-MAPEND-RABQoS-Negot |  | Ericsson | anders.molander@ericsson.com |
| 8402 | 60.3.2 | RAB Quality of Service Negotiation over Iu during relocation | 16d | 2001-03-02 A | 2001-03-23 A | 100% | 2001-03-02 | 2001-03-23 | 16d | start no earlier than 2001-03-02 | R3 | 128h | 128h | QoSPS-MAPEND-RABQoS-NegotReloc | Rel-4 | Juha | QoSPS-MAPEND-RABQoS-NegotReloc |  |  |  |
| 8403 | 60.3.3 | RAB Quality of Service Re-Negotiation over Iu | 130d | 2000-09-25 A | 2001-03-23 A | 100% | 2000-09-25 | 2001-03-23 | 130d | finish no earlier than 2001-03-23 | R3 | 1040h | 1040h | QoSPS-MAPEND-RABQoS-ReNegot | Rel-4 | Juha | QoSPS-MAPEND-RABQoS-ReNegot |  | Motorola | S. Irwin |

Notes:
- 8380: RAN and CN to verify no problems for GSM terminals roaming in 3G R99
- 8381: RAN and CN to verify UMTS_AMR_2 support
- 8382: -
- 8383: "Implementation" changed to "Impact on:" by A. Sultan (for better wording)
- 8384: RAN and CN to verify UMTS_AMR_2 support
- 8385: End date Modified from June to March to have it in Rel4
- 8386: Approved at CN#10. Acronym changed from ASCI, Rel-4
- 8387: CN4#11 30/11/02: no inputs received in CN4
- 8388: -
- 8389: -
- 8390: -
- 8391: -
- 8392: -
- 8393: -
- 8394: -
- 8395: -
- 8396: Completed WI missing from the P-plan Added for tracking
- 8397: -
- 8398: -
- 8399: -
- 8400: -
- 8401: -
- 8402: -
- 8403: -

| ID | WBS | Task | Type | Duration | Start | Finish | Complete | Baseline start | Baseline finish | Baseline duration | Constraint | Resources | Work | Actual work | Acronym | Release | MCC resp | Acronym_3GU_Export | TSG stopped | WI rapporteur name | WI rapporteur e-mail | Impacted TSs and TRs |
| --- | --- | --- | --- | --- | --- | --- | --- | --- | --- | --- | --- | --- | --- | --- | --- | --- | --- | --- | --- | --- | --- | --- |
| 8404 | 60.4 | **GERAN QoS Aspects - Handovers: maintenance of real-time QoS while moving between cells in the PLMN including inter-SGSN and SRNS relocation or possibly other mechanisms** |  | 501d | 2000-01-03 A | 2001-11-30 A | 100% | 2000-01-03 | 2001-11-30 | 501d |  | GP | 14456h | 14456h | GERQoS | Rel-4 | Paolo | GERQoS |  |  |  |  |
| 8405 | 60.4.1 | **Handover Concept for the PS domain** |  | 501d | 2000-01-03 A | 2001-11-30 A | 100% | 2000-01-03 | 2001-11-30 | 501d |  | GP | 10448h | 10448h |  | Rel-4 | Paolo |  |  |  |  |  |
| 8406 | 60.4.1.1 | Stable RT handover report 25.936 including header removal |  | 14d | 2000-01-03 A | 2000-01-19 A | 100% | 2000-01-03 | 2000-01-19 | 14d | start no earlier than 2000-01-03 | GP | 104h | 104h |  | Rel-4 | Paolo |  |  |  |  |  |
| 8407 | 60.4.1.2 | Update of stage 2 |  | 293d | 2000-01-03 A | 2001-02-13 A | 100% | 2000-01-03 | 2001-02-13 | 293d | finish no earlier than 2001-02-13 | GP | 2336h | 2336h |  | Rel-4 | Paolo |  |  |  |  |  |
| 8408 | 60.4.1.3 | Update of relevant stage 3 specs -> RRC |  | 501d | 2000-01-03 A | 2001-11-30 A | 100% | 2000-01-03 | 2001-11-30 | 501d | finish no earlier than 2001-11-30 | G2 | 4000h | 4000h |  | Rel-4 | Gert |  |  |  |  |  |
| 8409 | 60.5 | **Deleted - GERAN MS Conformance test for inter-system and intra-system Packet data real-time Handover** |  | 324d | 2001-08-31 A | 2002-11-27 A | 100% | 2001-08-31 | 2002-11-27 | 324d |  | G4; R3 | 25920h | 25920h | GERQoS-Mstest | Rel-4 | Paolo | GERQoS-Mstest | GP-12 |  |  |  |
| 8410 | 60.5.1 | **Deleted - Handover for the PS domain** |  | 324d | 2001-08-31 A | 2002-11-27 A | 100% | 2001-08-31 | 2002-11-27 | 324d |  | G4; R3 | 20736h | 20736h |  | Rel-4 | Paolo |  | GP-12 |  |  |  |
| 8411 | 60.5.1.1 | Deleted - Stable RT handover report 25.936 including header removal |  | 324d | 2001-08-31 A | 2002-11-27 A | 100% | 2001-08-31 | 2002-11-27 | 324d | finish no earlier than 2002-11-27 | G4; R3 | 5184h | 5184h |  | Rel-4 | Paolo |  | GP-12 |  |  |  |
| 8412 | 60.5.1.2 | Deleted - Update of stage 2 |  | 324d | 2001-08-31 A | 2002-11-27 A | 100% | 2001-08-31 | 2002-11-27 | 324d | finish no earlier than 2002-11-27 | G4; R3 | 5184h | 5184h |  | Rel-4 | Paolo |  | GP-12 |  |  |  |
| 8413 | 60.5.1.3 | Deleted - Update of relevant stage 3 specs |  | 324d | 2001-08-31 A | 2002-11-27 A | 100% | 2001-08-31 | 2002-11-27 | 324d | finish no earlier than 2002-11-27 | G4; R3 | 5184h | 5184h |  | Rel-4 | Paolo |  | GP-12 |  |  |  |
| 8414 | 60.6 | PS-domain handover for real-time services |  | 155d | 2000-08-28 A | 2001-03-30 A | 100% | 2000-08-28 | 2001-03-30 | 155d | finish no earlier than 2001-03-30 | R3 | 1240h | 1240h | QoSPS-PSdoRTS | Rel-4 | Juha | QoSPS-PSdoRTS |  | Nokia | atte.lansisalmi@nokia.com |  |
| 8415 | 60.7 | Deleted - RAB QoS Renegotiation at Relocation |  | 58d | 2001-01-03 A | 2001-03-23 A | 100% | 2001-01-03 | 2001-03-23 | 58d | finish no earlier than 2001-03-23 | R3 | 464h | 464h |  | Rel-4 | Juha |  | RP-11 |  |  | 25.851; 25.946 |
| 8416 | 61 | (Small) Technical Enhancements and Improvements for Rel-4 | milestone | 0d? | 2000-01-03 A | 2000-01-03 A | 100% | 2000-01-03 | 2001-03-30 | 326d? |  | SP; CP; RP; GP |  |  | TEI4 | Rel-4 | all | TEI4 |  |  |  |  |
| 8417 | 2510 | Test - (Small) Technical Enhancements and Improvements for Rel-4 |  | 326d? | 2000-01-03 A | 2001-03-30 A | 100% | 2000-01-03 | 2001-03-30 | 326d? | finish no earlier than 2008-12-31 | R5; T1 | 5216h | 5216h | TEI4_Test | Rel-4 | Ingbert | TEI4_Test |  |  |  |  |
| 8418 | 62 | **Rel-4 Evolutions of the transport in the UTRAN** |  | 525d | 2000-08-21 A | 2002-08-23 A | 100% | 2000-08-21 | 2002-08-23 | 525d |  | RP | 8600h | 8600h | ETRAN | Rel-4 | Issam | ETRAN |  | Alcatel | Francois Courau |  |
| 8419 | 62.1 | QoS optimization for AAL2 connections over Iub and Iur interfaces |  | 160d | 2000-08-21 A | 2001-03-30 A | 100% | 2000-08-21 | 2001-03-30 | 160d | finish no earlier than 2001-03-30 | R3 | 1280h | 1280h | ETRAN-QoSAAL2 | Rel-4 | Juha | ETRAN-QoSAAL2 |  | Japan Telecom | T. Yoshimura |  |
| 8420 | 62.2 | Transport bearer modification procedure on Iub, Iur, and Iu |  | 130d | 2000-10-02 A | 2001-03-30 A | 100% | 2000-10-02 | 2001-03-30 | 130d | finish no earlier than 2001-03-30 | R3 | 1040h | 1040h | ETRAN-MigrMod | Rel-4 | Juha | ETRAN-MigrMod |  | Japan Telecom | T. Yoshimura |  |
| 8421 | 62.3 | **Deleted - Conformance Test Aspects of Rel-4 evolutions of the transport in UTRAN** |  | 130d | 2002-02-25 A | 2002-08-23 A | 100% | 2002-02-25 | 2002-08-23 | 130d |  | T1 | 2080h | 2080h |  | Rel-4 | Ingbert |  | TP-17 |  |  |  |
| 8422 | 62.3.1 | Deleted - Testing RAB support enhancements |  | 130d | 2002-02-25 A | 2002-08-23 A | 100% | 2002-02-25 | 2002-08-23 | 130d | finish no earlier than 2002-08-23 | T1 | 1040h | 1040h | CT-RABS? | Rel-4 | Ingbert | CT-RABS? | TP-17 |  |  | 34.108; 34; 121; 34.122; 34.123 p 1.2; 34.123 pt 3 |
| 8423 | 63 | **Rel-4 Evolutions of the transport in the CN** |  | 215d | 2000-05-29 A | 2001-03-23 A | 100% | 2000-05-29 | 2001-03-23 | 215d |  | N4; N1; N2; S2 | 13128h | 13128h | CNTRSP | Rel-4 | Kimmo | CNTRSP |  |  |  |  |
| 8424 | 63.1 | **IP Transport of CN protocols (e.g. CAP, MAP)** |  | 77d | 2000-12-07 A | 2001-03-23 A | 100% | 2000-12-07 | 2001-03-23 | 77d |  | N4 | 2808h | 2808h | SS7IP | Rel-4 | Kimmo | SS7IP |  |  |  |  |
| 8425 | 63.1.1 | **Stage 3 for IP Transport of CN protocols (e.g. CAP, MAP)** |  | 77d | 2000-12-07 A | 2001-03-23 A | 100% | 2000-12-07 | 2001-03-23 | 77d |  | N4 | 2192h | 2192h |  | Rel-4 | Kimmo |  |  |  |  |  |
| 8426 | 63.1.1.1 | CAP |  | 77d | 2000-12-07 A | 2001-03-23 A | 100% | 2000-12-07 | 2001-03-23 | 77d | finish no earlier than 2001-03-23 | N2 | 616h | 616h |  | Rel-4 | Kimmo |  |  |  |  |  |
| 8427 | 63.1.1.2 | MAP |  | 77d | 2000-12-07 A | 2001-03-23 A | 100% | 2000-12-07 | 2001-03-23 | 77d | finish no earlier than 2001-03-23 | N4 | 616h | 616h |  | Rel-4 | Kimmo |  |  |  |  | 29.202 |
| 8428 | 63.1.1.3 | BSSAP+ |  | 43d | 2001-01-15 A | 2001-03-14 A | 100% | 2001-01-15 | 2001-03-14 | 43d | finish no earlier than 2001-03-14 | N1 | 344h | 344h | SS7IP-BSSAP+ | Rel-4 | Frederic | SS7IP-BSSAP+ |  |  |  |  |

Notes:
- 8404: -
- 8405: -
- 8406: -
- 8407: -
- 8408: -
- 8409: Still exist? To be clarified by GERAN4/5. Marked as stopped 12/2008
- 8410: Marked as stopped 12/2008
- 8411: Marked as stopped 12/2008
- 8412: Marked as stopped 12/2008
- 8413: Marked as stopped 12/2008
- 8414: -
- 8415: Marked as stopped 12/2008
- 8416: "Joker" WI, to be used for a Rel 4 CR not related to any feature and with very limited impact on the system
- 8417: "Joker" WI, to be used for small modifications applicable to Rel 4 conformance testing. Moved in from the Stoyan/Testing WP
- 8418: -
- 8419: -
- 8420: -
- 8421: Marked as stopped 12/2008
- 8422: Marked as stopped 12/2008
- 8423: -
- 8424: -
- 8425: -
- 8426: -
- 8427: -
- 8428: -

| ID | WBS | Task | Duration | Start | Finish | Complete | Baseline start | Baseline finish | Baseline duration | Constraint | Resources | Work | Actual work | WI rapporteur name | WI rapporteur e-mail | Release | MCC resp | Acronym | Acronym_3GU_Export | Impacted TSs and TRs | TSG stopped |
| --- | --- | --- | --- | --- | --- | --- | --- | --- | --- | --- | --- | --- | --- | --- | --- | --- | --- | --- | --- | --- | --- |
| 8429 | 63.2 | **FS on Transport and control separation in the PS CN domain** | 215d | 2000-05-29 A | 2001-03-23 A | 100% | 2000-05-29 | 2001-03-23 | 215d |  | S2 | 3440h | 3440h | Ericsson | Juan-Antonio.Ibanez@eed.ericsson.se | Rel-4 | Maurice |  |  |  |  |
| 8430 | 63.2.1 | Architectural impacts | 215d | 2000-05-29 A | 2001-03-23 A | 100% | 2000-05-29 | 2001-03-23 | 215d | finish no earlier than 2001-03-23 | S2 | 1720h | 1720h |  |  | Rel-4 | Maurice |  |  |  |  |
| 8431 | 64 | **Rel-4 Improvements of Radio Interface** | 700d | 2000-07-10 A | 2003-03-14 A | 100% | 2000-07-10 | 2003-03-14 | 700d |  | RP | 28624h | 28624h |  |  | Rel-4 |  |  |  |  |  |
| 8432 | 64.1 | UTRA repeater specification (master) | 183d | 2000-07-10 A | 2001-03-21 A | 100% | 2000-07-10 | 2001-03-21 | 183d | finish no earlier than 2001-03-21 | R4 | 1464h | 1464h | Mikom, Allgon | T. Kummetz, Mikom; Alf Ahlström, Allgon | Rel-4 | Issam | RInImp-REP | RInImp-REP |  |  |
| 8433 | 64.2 | DSCH power control improvement in soft handover | 140d | 2000-09-11 A | 2001-03-23 A | 100% | 2000-09-11 | 2001-03-23 | 140d | finish no earlier than 2001-03-23 | R1 | 1120h | 1120h | Nokia | antti.toskala@nokia.com | Rel-4 | Patrick | RInImp-DSCHsho | RInImp-DSCHsho |  |  |
| 8434 | 64.3 | UMTS 1800 | 320d | 2000-09-25 A | 2001-12-14 A | 100% | 2000-09-25 | 2001-12-14 | 320d | finish no earlier than 2001-12-14 | R4 | 2560h | 2560h | Motorola | Howard Benn | Rel-4 | Issam | RInImp-UMTS18 | RInImp-UMTS18 |  |  |
| 8435 | 64.4 | UMTS 1900 | 195d | 2001-03-19 A | 2001-12-14 A | 100% | 2001-03-19 | 2001-12-14 | 195d | finish no earlier than 2001-12-14 | R4 | 1560h | 1560h | Motorola | Howard Benn | Rel-4 | Issam | RInImp-UMTS19 | RInImp-UMTS19 | 25.101 |  |
| 8436 | 64.5 | FS on High Speed downlink packet access | 155d | 2000-08-21 A | 2001-03-23 A | 100% | 2000-08-21 | 2001-03-23 | 155d | finish no earlier than 2001-03-23 | R2 | 1240h | 1240h | Motorola | Amitabha Ghosh (qa0047@email.mot.com) | Rel-4 | Yong-Jun | RInImp-HSDPA | RInImp-HSDPA |  |  |
| 8437 | 64.6 | Deleted - FS on improved common DL channel for Cell-FACH state | 340d | 2000-09-11 A | 2001-12-28 A | 100% | 2000-09-11 | 2001-12-28 | 340d | finish no earlier than 2001-12-28 | R2 | 2720h | 2720h | GBT | J. Kwak | Rel-4 | Yong-Jun | RInImp-DLCFACH | RInImp-DLCFACH |  | RP-14 |
| 8438 | 64.7 | **Conformance Test Spec. Rel-4 improvements in Radio Interface** | 375d | 2001-10-08 A | 2003-03-14 A | 100% | 2001-10-08 | 2003-03-14 | 375d |  | T1 | 12360h | 12360h |  |  | Rel-4 | Ingbert |  |  |  |  |
| 8439 | 64.7.1 | Deleted - Testing Improved usage of downlink resource in FDD for CCTrCHs of dedicated type | 140d | 2002-02-18 A | 2002-08-30 A | 100% | 2002-02-18 | 2002-08-30 | 140d | finish no earlier than 2002-08-30 | T1 | 1120h | 1120h |  |  | Rel-4 | Ingbert |  |  |  | TP-17 |
| 8440 | 64.7.2 | Deleted - Testing Terminal Power saving features | 140d | 2002-02-18 A | 2002-08-30 A | 100% | 2002-02-18 | 2002-08-30 | 140d | finish no earlier than 2002-08-30 | T1 | 1120h | 1120h |  |  | Rel-4 | Ingbert |  |  |  | TP-17 |
| 8441 | 64.7.3 | Deleted - Testing DSCH power control improvement in soft handover | 140d | 2002-02-18 A | 2002-08-30 A | 100% | 2002-02-18 | 2002-08-30 | 140d | finish no earlier than 2002-08-30 | T1 | 1120h | 1120h |  |  | Rel-4 | Ingbert |  |  |  | TP-17 |
| 8442 | 64.7.4 | Testing UMTS 1800 | 180d | 2001-10-08 A | 2002-06-14 A | 100% | 2001-10-08 | 2002-06-14 | 180d | finish no earlier than 2002-06-14 | T1 | 1440h | 1440h |  |  | Rel-4 | Ingbert |  |  | 34.108; 34.121; 34.122; 34.123-1 |  |
| 8443 | 64.7.5 | Testing UMTS 1900 | 180d | 2001-10-08 A | 2002-06-14 A | 100% | 2001-10-08 | 2002-06-14 | 180d | finish no earlier than 2002-06-14 | T1 | 1440h | 1440h |  |  | Rel-4 | Ingbert |  |  | 34.108; 34.121; 34.122; 34.123-1 |  |
| 8444 | 64.7.6 | Testing UMTS 1800 - TTCN | 195d | 2002-06-17 A | 2003-03-14 A | 100% | 2002-06-17 | 2003-03-14 | 195d | finish no earlier than 2003-03-14 | T1 | 1560h | 1560h |  |  | Rel-4 | Ingbert |  |  | 34.123-3 |  |
| 8445 | 64.7.7 | Testing UMTS 1900 - TTCN | 195d | 2002-06-17 A | 2003-03-14 A | 100% | 2002-06-17 | 2003-03-14 | 195d | finish no earlier than 2003-03-14 | T1 | 1560h | 1560h |  |  | Rel-4 | Ingbert |  |  | 34.123-3 |  |
| 8446 | 65 | **Rel-4 RAN improvements** | 938d? | 2000-08-14 A | 2004-03-17 A | 100% | 2000-08-14 | 2004-03-17 | 938d? |  | RP | 29336h | 29336h |  |  | Rel-4 |  |  |  |  |  |
| 8447 | 65.1 | Node B synchronization for TDD | 160d | 2000-08-14 A | 2001-03-23 A | 100% | 2000-08-14 | 2001-03-23 | 160d | finish no earlier than 2001-03-23 | R1 | 1280h | 1280h | Siemens | S. Oestreich | Rel-4 | Patrick | RANimp-NBsync | RANimp-NBsync |  |  |
| 8448 | 65.2 | RAB support enhancement for Rel-4 | 155d | 2000-08-21 A | 2001-03-23 A | 100% | 2000-08-21 | 2001-03-23 | 155d | finish no earlier than 2001-03-23 | R2 | 1240h | 1240h | Ericsson | M. Israelsson, A. Krishnarajah | Rel-4 | Yong-Jun | RANimp-RABSE | RANimp-RABSE |  |  |
| 8449 | 65.4 | **Deleted - Conformance Test Aspects - Rel-4 RAN Improvements** | 577d? | 2002-01-01 A | 2004-03-17 A | 100% | 2002-01-01 | 2004-03-17 | 577d? |  | T1 | 19312h | 19312h |  |  | Rel-4 | Ingbert |  |  |  | TP-23 |
| 8450 | 65.4.1 | Deleted - Testing Radio access bearer support enhancments | 175d | 2002-01-01 A | 2002-09-02 A | 100% | 2002-01-01 | 2002-09-02 | 175d | finish no earlier than 2002-09-02 | T1 | 1400h | 1400h |  |  | Rel-4 | Ingbert |  |  |  | TP-17 |
| 8451 | 65.4.2 | Deleted - Testing RAB support enhancements-Robust Header Compression | 332d | 2002-05-28 A | 2003-09-03 A | 100% | 2002-05-28 | 2003-09-03 | 332d | finish no earlier than 2003-09-03 | T1 | 2656h | 2656h |  |  | Rel-4 | Ingbert | RABimp-RoCH | RABimp-RoCH | 34.123-1; -2 | TP-21 |
| 8452 | 65.4.3 | Deleted - Testing RAB support enhancements-Robust Header Compression - TTCN | 472d | 2002-05-28 A | 2004-03-17 A | 100% | 2002-05-28 | 2004-03-17 | 472d | finish no earlier than 2004-03-17 | T1 | 3776h | 3776h |  |  | Rel-4 | Ingbert |  |  | 34.123-3 | TP-23 |
| 8453 | 65.4.4 | Testing of Extended Robut Header Compression | 270d | 2002-09-18 A | 2003-09-30 A | 100% | 2002-09-18 | 2003-09-30 | 270d | finish no earlier than 2003-09-30 | T1 | 2160h | 2160h |  |  | Rel-4 | Ingbert | Ext-RoHC | Ext-RoHC | 34.123-1; -2 |  |
| 8454 | 65.4.5 | Deleted - Testing of Extended Robut Header Compression - TTCN | 325d | 2002-09-18 A | 2003-12-16 A | 100% | 2002-09-18 | 2003-12-16 | 325d | finish no earlier than 2003-12-16 | T1 | 2600h | 2600h |  |  | Rel-4 | Ingbert |  |  | 34.123-3 | TP-22 |
| 8455 | 2514.3.6 | Deleted - General changes to TS34.121 corresponding to release 4 | 263d? | 2003-03-03 A | 2004-03-03 A | 100% | 2003-03-03 | 2004-03-03 | 263d? | finish no earlier than 2004-03-03 | T1 | 2104h | 2104h |  |  | Rel-4 | Ingbert | RANimp-test,TEI4 | RANimp-test, TEI4 | 34.108; 34.121 | TP-23 |

Notes:
- 8429: -
- 8430: -
- 8431: -
- 8432: -
- 8433: -
- 8434: -
- 8435: -
- 8436: -
- 8437: Stopped at RP#14
- 8438: -
- 8439: Marked as stopped 12/2008
- 8440: Marked as stopped 12/2008
- 8441: Marked as stopped 12/2008
- 8442: -
- 8443: -
- 8444: -
- 8445: -
- 8446: -
- 8447: -
- 8448: 29 Nov 2000: split into ROHC and non-ROHC part¦5 Mar 2001: splitting off of ROHC for Rel-4 agreed by R2
- 8449: Marked as stopped 12/2008
- 8450: Marked as stopped 12/2008
- 8451: UID changed. Marked as stopped 12/2008
- 8452: UID changed. Marked as stopped 12/2008
- 8453: Marked as closed 12/2008 (was marked 15% complete)
- 8454: Marked as stopped 12/2008
- 8455: Marked as stopped 12/2008

| ID | WBS | Task | Duration | Start | Finish | Complete | Baseline start | Baseline finish | Baseline duration | Constraint | Resources | Work | Actual work | Acronym | WI rapporteur name | Release | MCC resp | Special Focus Doc | Acronym_3GU_Export | TSG stopped | WI rapporteur e-mail | Status Report |
| --- | --- | --- | --- | --- | --- | --- | --- | --- | --- | --- | --- | --- | --- | --- | --- | --- | --- | --- | --- | --- | --- | --- |
| 8456 | 66 | **Rel-4 Emergency call enhancements** | 628d | 2000-01-03 A | 2002-05-28 A | 100% | 2000-01-03 | 2002-05-28 | 628d |  | N1; S1; T1 | 18672h | 18672h | EMC1-CS | Ericsson | Rel-4 | Frederic | Public Safety (I-A) | EMC1, EMC1-CS |  |  |  |
| 8457 | 66.1 | **For CS based calls** | 628d | 2000-01-03 A | 2002-05-28 A | 100% | 2000-01-03 | 2002-05-28 | 628d |  | N1 | 3600h | 3600h | EMC1-CS | Ericsson | Rel-4 | Frederic | Public Safety (I-A) | EMC1-CS |  |  |  |
| 8458 | 66.1.1 | Distinction in CS domain of emergency call types to different emergency services | 40d | 2000-05-01 A | 2000-06-23 A | 100% | 2000-05-01 | 2000-06-23 | 40d | finish no earlier than 2000-06-23 | S1 | 320h | 320h |  |  | Rel-4 | Alain | Public Safety (I-A) |  |  |  |  |
| 8459 | 66.1.2 | Distinction in CS domain of emergency calls to different emergency types | 22d | 2000-08-24 A | 2000-09-22 A | 100% | 2000-08-24 | 2000-09-22 | 22d | finish no earlier than 2000-09-22 | N1 | 176h | 176h |  |  | Rel-4 | Frederic | Public Safety (I-A) |  |  |  |  |
| 8460 | 66.1.3 | Deleted - Conformance Test Aspects - Emergency call enhancements | 151d | 2000-01-03 A | 2000-07-28 A | 100% | 2000-01-03 | 2000-07-28 | 151d |  | T1 | 1200h | 1200h |  |  | Rel-4 | Ingbert | Public Safety (I-A) |  | TP-08 |  |  |
| 8461 | 66.1.4 | Testing CS based emergency calls | 67d | 2002-02-25 A | 2002-05-28 A | 100% | 2002-02-25 | 2002-05-28 | 67d | finish no earlier than 2002-05-28 | T1 | 536h | 536h |  |  | Rel-4 | Ingbert | Public Safety (I-A) |  |  |  |  |
| 8462 | 66.1.5 | Testing CS based emergency calls - TTCN | 134d | 2001-11-22 A | 2002-05-28 A | 100% | 2001-11-22 | 2002-05-28 | 134d | finish no earlier than 2002-05-28 | T1 | 1072h | 1072h |  |  | Rel-4 | Ingbert | Public Safety (I-A) |  |  |  |  |
| 8463 | 67 | **Rel-4 Terminal interfaces** | 315d | 2000-01-03 A | 2001-03-15 A | 100% | 2000-01-03 | 2001-03-15 | 315d |  | T2 | 14296h | 14296h | TI |  | Rel-4 | Kimmo |  | TI |  |  |  |
| 8464 | 67.1 | **AT commands enhancements** | 314d | 2000-01-03 A | 2001-03-14 A | 100% | 2000-01-03 | 2001-03-14 | 314d |  | T2 | 5016h | 5016h | TI-ATC |  | Rel-4 | Kimmo |  | TI-ATC |  |  |  |
| 8465 | 67.1.1 | Specification of AT commands for new services | 314d | 2000-01-03 A | 2001-03-14 A | 100% | 2000-01-03 | 2001-03-14 | 314d | finish no earlier than 2001-03-14 | T2 | 2504h | 2504h |  |  | Rel-4 | Kimmo |  |  |  |  |  |
| 8466 | 67.2 | **Wide Area Data Synchronization** | 314d | 2000-01-03 A | 2001-03-14 A | 100% | 2000-01-03 | 2001-03-14 | 314d |  | T2 | 5016h | 5016h | TI-WADS |  | Rel-4 | Kimmo |  | TI-WADS |  |  |  |
| 8467 | 67.2.1 | Continues evolution of Synchronization protocol | 314d | 2000-01-03 A | 2001-03-14 A | 100% | 2000-01-03 | 2001-03-14 | 314d | finish no earlier than 2001-03-14 | T2 | 2504h | 2504h | TI-SYNC-EVOL |  | Rel-4 | Kimmo |  | TI-SYNC-EVOL |  |  |  |
| 8468 | 67.3 | Terminal local model | 218d | 2000-05-16 A | 2001-03-15 A | 100% | 2000-05-16 | 2001-03-15 | 218d | finish no earlier than 2001-03-15 | T2 | 1744h | 1744h | TLM | Ericsson | Rel-4 | Kimmo |  | TLM |  | Olga.Tome@ECS.ERICSSON.SE |  |
| 8469 | 68 | **Rel-4 Location Services enhancements** | 455d | 2000-04-03 A | 2001-12-28 A | 100% | 2000-04-03 | 2001-12-28 | 455d |  | S2; S1; T2; N1; N4; R3; R2 | 67671.2h | 67671.2h | LCS4 | Nokia | Rel-4 | Maurice |  | LCS1 |  | Jan Kall |  |
| 8470 | 68.1 | CBS interactions | 455d | 2000-04-03 A | 2001-12-28 A | 100% | 2000-04-03 | 2001-12-28 | 455d | finish no earlier than 2001-12-28 | T2 | 3640h | 3640h | LCS4-CBS |  | Rel-4 |  |  | LCS1-CBS |  |  |  |
| 8471 | 68.2 | LCS support in the CS domain | 180d | 2000-05-15 A | 2001-01-19 A | 100% | 2000-05-15 | 2001-01-19 | 180d | finish no earlier than 2001-01-19 | S2 | 1440h | 1440h | LCS4-CS |  | Rel-4 | Maurice |  | LCS1-CS |  |  |  |
| 8472 | 68.3 | **LCS support in the PS domain** | 435d | 2000-05-01 A | 2001-12-28 A | 100% | 2000-05-01 | 2001-12-28 | 435d |  | S2; S1; N1; N4 | 29880h | 29880h | LCS4-PS |  | Rel-4 | Maurice |  | LCS1-PS |  |  |  |
| 8473 | 68.3.1 | Stage 1 for LCS support in the PS domain | 40d | 2000-07-03 A | 2000-08-25 A | 100% | 2000-07-03 | 2000-08-25 | 40d | start no earlier than 2000-07-03 | S1 | 320h | 320h |  | Pacific Bell Wireless | Rel-4 | Alain |  |  |  | Randolph Wohlert (rwohlert@tri.sbc.com) |  |
| 8474 | 68.3.2 | Stage 2 for LCS support in the PS domain | 190d | 2000-05-01 A | 2001-01-19 A | 100% | 2000-05-01 | 2001-01-19 | 190d | finish no earlier than 2001-01-19 | S2; R2; G1 | 4560h | 4560h |  |  | Rel-4 | Maurice |  |  |  |  |  |
| 8475 | 68.3.3 | **Stage 3 for LCS support in the PS domain** | 355d | 2000-08-21 A | 2001-12-28 A | 100% | 2000-08-21 | 2001-12-28 | 355d |  | N1; N4 | 11080h | 11080h |  |  | Rel-4 | Frederic |  |  |  |  |  |
| 8476 | 68.3.3.1 | Layer 3 LCS signalling UE (MS) -SGSN (UMTS PS and and GSM-GPRS) | 355d | 2000-08-21 A | 2001-12-28 A | 100% | 2000-08-21 | 2001-12-28 | 355d | finish no earlier than 2001-12-28 | N1 | 2840h | 2840h |  | Nokia | Rel-4 | Frederic |  |  |  | Janne Muhonen |  |
| 8477 | 68.3.3.2 | MAP impacts of LCS | 160d | 2000-08-21 A | 2001-03-30 A | 100% | 2000-08-21 | 2001-03-30 | 160d | finish no earlier than 2001-03-30 | N4 | 1280h | 1280h |  |  | Rel-4 | Kimmo |  |  |  |  |  |
| 8478 | 68.3.3.3 | GTP signalling for LCS | 160d | 2000-08-21 A | 2001-03-30 A | 100% | 2000-08-21 | 2001-03-30 | 160d | finish no earlier than 2001-03-30 | N4 | 1280h | 1280h |  |  | Rel-4 | Kimmo |  |  |  |  |  |
| 8479 | 68.4 | **UE positioning Rel-4** | 260d | 2000-04-03 A | 2001-03-30 A | 100% | 2000-04-03 | 2001-03-30 | 260d |  | R3; R2 | 7231.2h | 7231.2h | LCS1-UEpos |  | Rel-4 | Issam |  | LCS1-UEpos |  |  | RP-010045 |
| 8480 | 68.4.1 | Iub/Iur interfaces for methods Rel 99 | 233.9d | 2000-04-03 A | 2001-03-30 A | 100% | 2000-04-03 | 2001-03-30 | 233.9d | finish no earlier than 2001-03-30 | R3 | 1871.2h | 1871.2h | LCS1-UEpos-IubIur | Ericsson | Rel-4 | Juha |  | LCS1-UEpos-IubIur |  | Yun-Chao Hu | RP-010045 |
| 8481 | 68.4.2 | UE positioning enhancements - IPDL for TDD | 150d | 2000-08-28 A | 2001-03-23 A | 100% | 2000-08-28 | 2001-03-23 | 150d | finish no earlier than 2001-03-23 | R2 | 1200h | 1200h | LCS1-UEpos-enh | Siemens | Rel-4 | Yong-Jun |  | LCS1-UEpos-enh |  | Armin Sitte | RP-010045 |

Notes:
- 8456: Acronym changed from EMC1, EMC1-CS
- 8457: WI approved in TSG_10
- 8458: -
- 8459: Calls to different emergency services such as ambulance, fire brigade, police, etc. can be routed to respective different emergency centres. / Impacted TSs and TRs: 24.008
- 8460: UID changed. Marked as stopped 12/2008
- 8461: - / Impacted TSs and TRs: 34.123-1
- 8462: - / Impacted TSs and TRs: 34.123-3
- 8463: -
- 8464: - / Impacted TSs and TRs: 27.007
- 8465: goal not completely achieved because of missing input / Impacted TSs and TRs: 27.007
- 8466: AS: Rel5 changed to Rel4 according to SP#10 decision, milestone on testing added
- 8467: - / Impacted TSs and TRs: 27.903; 27.103
- 8468: - / Impacted TSs and TRs: 23.227
- 8469: Acronym changed form LCS1
- 8470: - / Impacted TSs and TRs: 23.041
- 8471: Only MAP impact foreseen so far. To be further split if needed.
- 8472: -
- 8473: To be also considered: External LCS client identity, and Privacy options when PDP-context and when no PDP-context is established / Impacted TSs and TRs: 22.071
- 8474: SP#10 completed / Impacted TSs and TRs: 25.305 (UTRAN part); new 23.271 (CN part by S2; 43.059 (GERAN part)
- 8475: -
- 8476: -
- 8477: -
- 8478: -
- 8479: -
- 8480: - / Impacted TSs and TRs: 25.401; 25.420; 25.423; 25.430; 25.433; new 25.850
- 8481: 5 Mar 2001: split of IPDL for TDD agreed by R2 / Impacted TSs and TRs: new 25.847

| ID | WBS | Task | Duration | Start | Finish | Complete | Baseline start | Baseline finish | Baseline duration | Constraint | Resources | Work | Actual work | Acronym | Release | MCC resp | Acronym_3GU_Export | Impacted TSs and TRs | WI rapporteur name | WI rapporteur e-mail | TSG stopped |
| --- | --- | --- | --- | --- | --- | --- | --- | --- | --- | --- | --- | --- | --- | --- | --- | --- | --- | --- | --- | --- | --- |
| 8482 | 69 | **Rel-4 UICC/(U)SIM enhancements and interworking** | 175d | 2000-07-24 A | 2001-03-23 A | 100% | 2000-07-24 | 2001-03-23 | 175d |  | T3 | 2800h | 2800h | UICC1 | Rel-4 | Xavier | UICC1, Rel-4 |  |  |  |  |
| 8483 | 69.1 | Common PCN Handset Specification (CPHS) | 175d | 2000-07-24 A | 2001-03-23 A | 100% | 2000-07-24 | 2001-03-23 | 175d | finish no earlier than 2001-03-23 | T3 | 1400h | 1400h | UICC1-CPHS | Rel-4 | Xavier | UICC1-CPHS | 27.103 | One2One |  |  |
| 8484 | 70 | **Rel-4 (U)SIM toolkit enhancements** | 210d | 2000-06-05 A | 2001-03-23 A | 100% | 2000-06-05 | 2001-03-23 | 210d |  | T3; S1 | 6720h | 6720h | USAT4 | Rel-4 | Xavier | USAT1, USAT1-LocLnk, USAT1APIJAVA, USAT1SM | 23.048 (USAT1SM); 43.019 (USAT1APIJAVA) | Gemplus | Jean-Francois Rubon |  |
| 8485 | 70.1 | USAT local link | 210d | 2000-06-05 A | 2001-03-23 A | 100% | 2000-06-05 | 2001-03-23 | 210d | finish no earlier than 2001-03-23 | T3; S1 | 3360h | 3360h | USAT1-LocLnk | Rel-4 | Xavier | USAT1-LocLnk | 22.038; 31.111 | Gemplus | Jean-Francois Rubon |  |
| 8486 | 71 | **Rel-4 Security enhancements** | 576d | 2000-01-03 A | 2002-03-15 A | 100% | 2000-01-03 | 2002-03-15 | 576d |  | S3; N4; N1 | 38112h | 38112h | SEC4 | Rel-4 | Mirko | SEC1 |  | Vodafone | Peter.Howard@vodafone.com |  |
| 8487 | 54.2 | Rel-4 Lawful Interception | 155d | 2000-08-21 A | 2001-03-23 A | 100% | 2000-08-21 | 2001-03-23 | 155d | finish no earlier than 2001-03-23 | S3 | 1240h | 1240h | SEC4-LI | Rel-4 | Mirko | SEC1-LI | 33.107 |  |  |  |
| 8488 | 71.1 | Evolution of GSM CS algorithms (e.g. A5/3 development and deployment) | 272d | 2000-01-03 A | 2001-01-15 A | 100% | 2000-01-03 | 2001-01-15 | 272d | finish no earlier than 2001-01-15 | S3 | 2168h | 2168h | SEC1-CSALGO1 | Rel-4 | Mirko | SEC1-CSALGO1 | 33.102; 33.103; 33.105 | DTI, BIS | cbrookson@iee.org |  |
| 8489 | 71.2 | **Evolution of GSM PS algorithms (e.g. GEA 2 deployment)** | 219d | 2000-02-22 A | 2000-12-22 A | 100% | 2000-02-22 | 2000-12-22 | 219d |  | S3; N4; N1 | 9528h | 9528h | SEC1-PSALGO1 | Rel-4 | Mirko | SEC1-PSALGO1 | 33.102; 33.103; 33.105 | DTI, BIS | cbrookson@iee.org |  |
| 8490 | 71.2.1 | Deleted - Main aspects of Evolution of GSM PS algorithms (e.g. GEA 2 deployment) | 199d | 2000-02-22 A | 2000-11-24 A | 100% | 2000-02-22 | 2000-11-24 | 199d | finish no earlier than 2000-11-24 | S3 | 1592h | 1592h |  | Rel-4 | Mirko |  |  | DTI, BIS | cbrookson@iee.org | SP-69 |
| 8491 | 71.2.2 | Impact on GTP | 200d | 2000-03-20 A | 2000-12-22 A | 100% | 2000-03-20 | 2000-12-22 | 200d | finish no earlier than 2000-12-22 | N4 | 1600h | 1600h |  | Rel-4 | Kimmo |  |  | DTI, BIS | cbrookson@iee.org |  |
| 8492 | 71.2.3 | GEA capability indication in MS CM | 135d | 2000-06-19 A | 2000-12-22 A | 100% | 2000-06-19 | 2000-12-22 | 135d | finish no earlier than 2000-12-22 | N1 | 1080h | 1080h | SEC1-PSALGO1-GEACAP | Rel-4 | Frederic | SEC1-PSALGO1-GEACAP |  | Vodafone Airtouch | Duncan Mills |  |
| 8493 | 71.3 | **Deleted - MAP application layer security** | 576d | 2000-01-03 A | 2002-03-15 A | 100% | 2000-01-03 | 2002-03-15 | 576d |  | S3 | 11352h | 11352h | SEC1-MAPAL | Rel-4 | Mirko | SEC1-MAPAL |  |  |  | SP-15 |
| 8494 | 71.3.1 | Deleted - Main aspects of MAP application layer security | 199d | 2000-02-21 A | 2001-03-29 A | 100% | 2000-02-21 | 2001-03-29 | 199d | start no earlier than 2000-02-21 | S3 | 1592h | 1592h |  | Rel-4 | Mirko |  |  |  |  | SP-11 |
| 8495 | 71.3.2 | Deleted - Other stage 3 aspects | 199d | 2000-02-22 A | 2000-11-24 A | 100% | 2000-02-22 | 2000-11-24 | 199d | finish no earlier than 2000-11-24 | N4 | 1592h | 1592h |  | Rel-4 | Kimmo |  |  |  |  | CP-10 |
| 8496 | 71.3.3 | Deleted - Visibility and Configurability of security | 576d | 2000-01-03 A | 2002-03-15 A | 100% | 2000-01-03 | 2002-03-15 | 576d | finish no earlier than 2002-03-15 | S3 | 4600h | 4600h | SEC1-VCS | Rel-4 | Mirko | SEC1-VCS |  | France Telecom | Sebastien.nguyenngoc@rd.francetelecom.com | SP-15 |
| 8497 | 72 | **Rel-4 Charging and OAM&P** | 221d | 2000-12-01 A | 2001-10-05 A | 100% | 2000-12-01 | 2001-10-05 | 221d |  | S5 | 10472h | 10472h | OAM4 | Rel-4 | Mirko | OAM4 |  |  |  |  |
| 8498 | 72.1 | Rel-4 Principles, high level Requirements and Architecture | 145d | 2000-12-01 A | 2001-06-21 A | 100% | 2000-12-01 | 2001-06-21 | 145d | finish no earlier than 2001-06-21 | S5 | 1160h | 1160h |  | Rel-4 | Mirko |  | 32.101; 32.102 | Motorola, Telia | Michael.Truss@motorola.com, Tommy.R.Berggren@TELIA.SE |  |
| 8499 | 72.2 | Rel-4 Performance Management | 216d | 2000-12-01 A | 2001-09-28 A | 100% | 2000-12-01 | 2001-09-28 | 216d | finish no earlier than 2001-06-21 | S5 | 1728h | 1728h |  | Rel-4 | Mirko |  | 32.4xy; 52.402 | T-Mobile | karl-heinz.nenner@t-mobile.de |  |
| 8500 | 72.3 | Fault Management | 221d | 2000-12-01 A | 2001-10-05 A | 100% | 2000-12-01 | 2001-10-05 | 221d | finish no earlier than 2001-06-21 | S5 | 1768h | 1768h |  | Rel-4 | Mirko |  | 32.111-1/4 | Lucent |  |  |
| 8501 | 72.4 | Configuration Management | 145d | 2000-12-01 A | 2001-06-21 A | 100% | 2000-12-01 | 2001-06-21 | 145d | finish no earlier than 2001-06-21 | S5 | 1160h | 1160h |  | Rel-4 | Mirko |  | 32.106-1/8 | Ericsson | thomas.tovinger@ericsson.com |  |
| 8502 | 72.5 | Rel-4 Charging Management | 216d | 2000-12-01 A | 2001-09-28 A | 100% | 2000-12-01 | 2001-09-28 | 216d | finish no earlier than 2001-06-21 | S5 | 1728h | 1728h |  | Rel-4 | Mirko |  | 32.200; 32.205; 32.215; 32.235 | T-Mobile | karl-heinz.nenner@t-mobile.de |  |
| 8503 | 72.6 | UTRAN Operations and Maintenance procedures | 145d | 2000-12-01 A | 2001-06-21 A | 100% | 2000-12-01 | 2001-06-21 | 145d | finish no earlier than 2001-06-21 | S5 | 1160h | 1160h | UOAM | Rel-4 | Mirko | UOAM | 32.800 | Mannesmann Mobilfunk | bert.boden@d2mannesmann.de |  |
| 8504 | 73 | **Global Text Telephony** | 317d? | 2000-01-03 A | 2001-03-19 A | 100% | 2000-01-03 | 2009-09-18 | 2537d? |  | S1; S2; S4; T1; R5 | 18528h | 18528h | GTT | Rel-4 | Maurice | GTT |  | Ericsson | gunnar.hellstrom@omnitor.se |  |
| 8505 | 73.1 | Stage 1 for Global Text Telephony | 188d | 2000-04-05 A | 2000-12-22 A | 100% | 2000-04-05 | 2000-12-22 | 188d | finish no earlier than 2000-12-22 | S1 | 1504h | 1504h |  | Rel-4 | Alain |  | 22.226 |  |  |  |
| 8506 | 73.2 | Stage 2 for Global Text Telephony | 206d | 2000-01-03 A | 2000-10-13 A | 100% | 2000-01-03 | 2000-10-13 | 206d |  | S2 | 1640h | 1640h |  | Rel-4 | Maurice |  | 23.226 |  |  |  |

Notes:
- 8482: Acronym changed from UICC1, Rel-4
- 8483: 28/5/2001: CRs approved at TP-11. WI complete.
- 8484: Acronym changed from USAT1, USAT1-LocLnk, USAT1APIJAVA, USAT1SM
- 8485: 25/5/2001:CR was approved at TP-11. WI is complete
- 8486: acronym changed from SEC1
- 8487: Requirements capture: S3#14 (Aug 00), Feature specification: S3#15 (Sep 00), Definition of architecture. Should be included in general LI work mentioned above.. Acronym changed from SEC1-LI
- 8488: SP#8 approved WID
- 8489: SP#8 approved WID
- 8490: Complete TSG#09 (09/2000). S3#17: Proposed for deletion. TO BE DELETED
- 8491: -
- 8492: -
- 8493: REPLACED BY NDS-MAP and NDS-IP. Completed Auto Key Management -> Rel-6. Marked as stopped 12/2008
- 8494: UID changed. Marked as stopped 12/2008
- 8495: UID changed. Marked as stopped 12/2008
- 8496: CR approved at SA3#21 awaiting comments from CN1. Marked as stopped 12/2008
- 8497: SP#13 approved WID
- 8498: -
- 8499: -
- 8500: -
- 8501: -
- 8502: -
- 8503: -
- 8504: SP#12 updated WID SP-000162=>SP-010340
- 8505: -
- 8506: -

| ID | WBS | Task | Type | Duration | Start | Finish | Complete | Baseline start | Baseline finish | Baseline duration | Constraint | Resources | Work | Actual work | Acronym | Release | MCC resp | Acronym_3GU_Export | PCG stopped | TSG stopped |
| --- | --- | --- | --- | --- | --- | --- | --- | --- | --- | --- | --- | --- | --- | --- | --- | --- | --- | --- | --- | --- |
| 8507 | 73.3 | **Specification of Cellular Text telephone Modem** |  | 136d | 2000-09-11 A | 2001-03-19 A | 100% | 2000-09-11 | 2001-03-19 | 136d |  | S4 | 2704h | 2704h | GTT-CTM | Rel-4 | Paolo | GTT-CTM |  |  |
| 8508 | 73.3.1 | General description and C-code |  | 66d | 2000-09-11 A | 2000-12-11 A | 100% | 2000-09-11 | 2000-12-11 | 66d | finish no earlier than 2000-12-11 | S4 | 528h | 528h |  | Rel-4 | Paolo |  |  |  |
| 8509 | 73.3.2 | Minimum Performance requirements |  | 136d | 2000-09-11 A | 2001-03-19 A | 100% | 2000-09-11 | 2001-03-19 | 136d | finish no earlier than 2001-03-19 | S4 | 1088h | 1088h |  | Rel-4 | Paolo |  |  |  |
| 8510 | 73.5 | Deleted - Conformance Test Aspects - Global Text Telephony | milestone | 0d? | 2000-09-21 A | 2000-09-21 A | 100% | 2000-09-21 | 2009-09-18 | 2348d? | finish no earlier than 2009-09-18 | R5; T1 |  |  | GTT_Test | Rel-4 | Ingbert | GTT_Test | PCG-23 | RP-45 |
| 8511 | 2523 | --- RELEASE 99 --- |  | 261d? | 2000-01-03 A | 2000-12-29 A | 100% | 2000-01-03 | 2000-12-29 | 261d? |  | NP; SP; TP; SMG | 8352h | 8352h |  | R99 | All |  |  |  |
| 8512 | 2524 | **UMTS Features** |  | 261d? | 1999-01-01 A | 1999-12-31 A | 100% | 1999-01-01 | 1999-12-31 | 261d? |  | S1; S2; S4; SMG; N3; N4; RP | 39672h | 39672h |  | R99 | Alain |  |  |  |
| 8513 | 2524.1 | UMTS_SERVICES |  | 261d? | 1999-01-01 A | 1999-12-31 A | 100% | 1999-01-01 | 1999-12-31 | 261d? | start no earlier than 1999-01-01 | S1 | 2088h | 2088h | UMTS_SERVICES | R99 | Alain | UMTS_SERVICES |  |  |
| 8514 | 2524.2 | UMTS phase 1 |  | 261d? | 1999-01-01 A | 1999-12-31 A | 100% | 1999-01-01 | 1999-12-31 | 261d? | start no earlier than 1999-01-01 | S1 | 2088h | 2088h | UMTS1 | R99 | Alain | UMTS1 |  |  |
| 8515 | 2524.3 | UMTS Capabilities |  | 261d? | 1999-01-01 A | 1999-12-31 A | 100% | 1999-01-01 | 1999-12-31 | 261d? | start no earlier than 1999-01-01 | S1 | 2088h | 2088h | UMTS_Capabil | R99 | Alain | UMTS_Capabil |  |  |
| 8516 | 2524.4 | Architecture of the GSM-UMTS platform |  | 261d? | 1999-01-01 A | 1999-12-31 A | 100% | 1999-01-01 | 1999-12-31 | 261d? | start no earlier than 1999-01-01 | S2; N4 | 4176h | 4176h |  | R99 | Maurice |  |  |  |
| 8517 | 2524.5 | UMTS Terrestrial Radio Access Network |  | 261d? | 1999-01-01 A | 1999-12-31 A | 100% | 1999-01-01 | 1999-12-31 | 261d? | start no earlier than 1999-01-01 | RP | 2088h | 2088h | UTRAN | R99 | Yong-Jun | UTRAN |  |  |
| 8518 | 2524.6 | UMTS 1800, UMTS 1900 |  | 261d? | 1999-01-01 A | 1999-12-31 A | 100% | 1999-01-01 | 1999-12-31 | 261d? | start no earlier than 1999-01-01 | R2 | 2088h | 2088h | Rlnlmp19,Rlnlmp18 | R99 | Yong-Jun | Rlnlmp19, Rlnlmp18 |  |  |
| 8519 | 2524.7 | Mandatory speech codec for narrowband telephony service |  | 261d? | 1999-01-01 A | 1999-12-31 A | 100% | 1999-01-01 | 1999-12-31 | 261d? | start no earlier than 1999-01-01 | S4 | 2088h | 2088h | Mandatory_Speech_Codec,AMR-NB,AMR | R99 | Paolo | Mandatory_Speech_Codec, AMR-NB, AMR |  |  |
| 8520 | 2524.8 | Codec for low bitrate multimedia telephony service |  | 261d? | 1999-01-01 A | 1999-12-31 A | 100% | 1999-01-01 | 1999-12-31 | 261d? | start no earlier than 1999-01-01 | S4 | 2088h | 2088h | Low_bit_rate_codec_for_MM_Tel.,H.324M | R99 | Paolo | Low_bit_rate_codec_for_MM_Tel., H.324M |  |  |
| 8521 | 2524.9 | 3G Audio-Visual Terminal characteristics |  | 261d? | 1999-01-01 A | 1999-12-31 A | 100% | 1999-01-01 | 1999-12-31 | 261d? | start no earlier than 1999-01-01 | S4 | 2088h | 2088h | WI5TAC,3G-AVT,Terminal_Acoustic_Characteristics | R99 | Paolo | WI5TAC, 3G-AVT, Terminal_Acoustic_Characteristics |  |  |
| 8522 | 2524.10 | Updates_for_UMTS |  | 261d? | 1999-01-01 A | 1999-12-31 A | 100% | 1999-01-01 | 1999-12-31 | 261d? | start no earlier than 1999-01-01 | N3 | 2088h | 2088h | Updates_for_UMTS | R99 | Gwiho | Updates_for_UMTS |  |  |
| 8523 | 2524.11 | UMTS |  | 261d? | 1999-01-01 A | 1999-12-31 A | 100% | 1999-01-01 | 1999-12-31 | 261d? | start no earlier than 1999-01-01 | N3 | 2088h | 2088h | UMTS | R99 | Gwiho | UMTS |  |  |
| 8524 | 2525 | **UMTS and GSM Features** |  | 261d? | 1999-01-01 A | 1999-12-31 A | 100% | 1999-01-01 | 1999-12-31 | 261d? |  | S1; S2; SMG; T2; N1; N2; N3; N4; R2; R3 | 219240h | 219240h |  | R99 | Alain |  |  |  |
| 8525 | 2525.1 | Multimedia Messaging Service |  | 261d? | 1999-01-01 A | 1999-12-31 A | 100% | 1999-01-01 | 1999-12-31 | 261d? | start no earlier than 1999-01-01 | T2 | 2088h | 2088h | MMS | R99 |  | MMS |  |  |
| 8526 | 2525.2 | Location Services |  | 261d? | 1999-01-01 A | 1999-12-31 A | 100% | 1999-01-01 | 1999-12-31 | 261d? | start no earlier than 1999-01-01 | S1; S2; S3; SMG1; SMG2; SMG12; N1; N2; N4; R2; R3 | 22968h | 22968h | LCS | R99 | Alain | LCS |  |  |
| 8527 | 2525.3 | **Customised Application for Mobile network Enhanced Logic Phase 3** |  | 261d? | 1999-01-01 A | 1999-12-31 A | 100% | 1999-01-01 | 1999-12-31 | 261d? |  | S1; S2; N2; N4 | 18792h | 18792h | CAMEL3 | R99 | Alain | CAMEL3 |  |  |
| 8528 | 2525.3.1 | Global view |  | 261d? | 1999-01-01 A | 1999-12-31 A | 100% | 1999-01-01 | 1999-12-31 | 261d? | start no earlier than 1999-01-01 | S1; S2; N2; N4 | 8352h | 8352h |  | R99 | Alain |  |  |  |
| 8529 | 2525.3.2 | Multiple Subscriber Profile (MSP) based on CAMEL phase 3 |  | 261d? | 1999-01-01 A | 1999-12-31 A | 100% | 1999-01-01 | 1999-12-31 | 261d? | start no earlier than 1999-01-01 | S1 | 2088h | 2088h |  | R99 | Alain |  |  |  |
| 8530 | 2525.4 | Short Message Service enhancements / Enhanced Messaging Service (EMS) |  | 261d? | 1999-01-01 A | 1999-12-31 A | 100% | 1999-01-01 | 1999-12-31 | 261d? | start no earlier than 1999-01-01 | T2 | 2088h | 2088h | EMS | R99 |  | EMS |  |  |
| 8531 | 2525.5 | Mobile Station Execution Environment |  | 261d? | 1999-01-01 A | 1999-12-31 A | 100% | 1999-01-01 | 1999-12-31 | 261d? | start no earlier than 1999-01-01 | S1; SMG1; T2 | 6264h | 6264h | MExE | R99 | Alain | MExE |  |  |
| 8532 | 2525.6 | MS_Classmark |  | 261d? | 1999-01-01 A | 1999-12-31 A | 100% | 1999-01-01 | 1999-12-31 | 261d? | start no earlier than 1999-01-01 | N1 | 2088h | 2088h | MS_Classmark | R99 | Frederic | MS_Classmark |  |  |

Notes:
- 8507: -
- 8508: - / Impacted TSs and TRs: 26.226; 26.230
- 8509: - / Impacted TSs and TRs: 26.231
- 8510: RP#45 work item abandoned/closed (it was never really started)
- 8511: -
- 8512: -
- 8513: - / Impacted TSs and TRs: 22.101
- 8514: - / Impacted TSs and TRs: 22.100
- 8515: Requirement for high quality speech in UMTS Phase 1 but not in R99 / Impacted TSs and TRs: 22.105
- 8516: wid Architecture overview of the GSM-UMTS System, Architecture the GSM-UMTS Platform and New Access Network to Core Network (BSS-NSS) interface / Impacted TSs and TRs: 23.002; 23.008; 23.060; 23.101; 23.110
- 8517: - / Impacted TSs and TRs: 22.011; 22.038; 22.060; 22.078; 22.100; 22.101; 22.105; 22.115; 22.129; 23.002; 23.060; 24.007; 24.008; 25.101; 25.102; 25.104; 25.105; 25.113; 25.123; 25.133; 25.141; 25.142; 25.201; 25.211; 25.212; 25.213; 25.214; 25.215; 25.221; 25.222; 25.223; 25.224.
- 8518: - / Impacted TSs and TRs: 25.307 CR#0002; 0003 Inclusion of release independent RF related information
- 8519: Define the default speech codec for UMTS (both for FDD and TDD). Definition limited to selection of one codec among several existing ones/proposed codecs: GSM AMR, IS127 EVRC, ITU G.729 and MPEG-4 speech codec. / Impacted TSs and TRs: 04.08; 05.01; 05.02; 05.03; 05.05; 05.08; 05.09; 05.09; 05.50; 08.60; 08.61; 11.21; 26.071; 26.073; 26.074; 26.090; 26.091; 26.092; 26.093; 26.094; 26.101; 26.102; 26.103; 26.104; 26.975
- 8520: - / Impacted TSs and TRs: 26.104; 26.110; 26.111; 26.911; 26.912; 26.915
- 8521: - / Impacted TSs and TRs: 26.131; 26.132
- 8522: - / Impacted TSs and TRs: 24.022; 27.001; 29.007
- 8523: - / Impacted TSs and TRs: 27.060; 29.061
- 8524: -
- 8525: MMS allows users to send/receive messages e.g. almost unlimited text length, images, audio and video clips and new content types. R99 only includes the concept. MMS stage 3 is not included in 23.140. Rel-4 adds detailed architecture and protocols. / Impacted TSs and TRs: 22.140; 23.040; 23.140
- 8526: LCS provide ability to localize a terminal / Impacted TSs and TRs: 02.07; 03.71; 04.31; 04.35; 04.71; 05.05; 08.08; 08.31; 08.71; 09.31; 22.071; 23.002; 23.003; 23.007; 23.008; 23.016; 23.018; 23.032; 23.171; 24.007; 24.008; 24.030; 24.080; 25.305; 25.306; 25.331; 25.413; 25.423; 29.002; 29.010
- 8527: CAMEL is a network feature providing mechanisms to support services of operators which are not covered by standardised services, even when roaming outside the HPLMN. / Impacted TSs and TRs: 22.101; 23.008; 23.012; 23.016; 23.018; 23.060; 23.072; 23.078; 23.079; 23.082; 23.093; 29.002; 29.078
- 8528: - / Impacted TSs and TRs: 22.078; 23.078; 29.078
- 8529: MSP is an optional service enabling mobile subscribers to have several profiles associated with a single IMSI, with each profile being a subscription option. Each profile may be used for mobile originated and mobile terminated calls. / Impacted TSs and TRs: 22.097 (Advanced Addressing)
- 8530: SMS for 3G terminals compatible with GSM SMS. Added Enhanced Messaging Service (EMS) allowing small pictures, sounds, animations to be transferred via SMS. / Impacted TSs and TRs: 23.038; 23.039; 23.040; 23.042
- 8531: MExE provides a standardized MS execution environment and ability to negotiate its supported capabilities with a MExE SP. R99 enhances SIM MExE certificate management, security clarifications, QoS and defines two MExE classmarks WAP/Personal-Java based. / Impacted TSs and TRs: 02.57; 22.057; 22.101; 23.057
- 8532: MExE classmark identifies a category of MExE UE supporting MExE functionality with a minimum level of processing, memory, display, and interactive capabilities. Several MExE classmarks may be defined. / Impacted TSs and TRs: 24.008

| ID | WBS | Task | Duration | Start | Finish | Complete | Baseline start | Baseline finish | Baseline duration | Constraint | Resources | Work | Actual work | Acronym | Release | MCC resp | Acronym_3GU_Export | TSG stopped |
| --- | --- | --- | --- | --- | --- | --- | --- | --- | --- | --- | --- | --- | --- | --- | --- | --- | --- | --- |
| 8533 | 2525.7 | **MultiCall** | 261d? | 1999-01-01 A | 1999-12-31 A | 100% | 1999-01-01 | 1999-12-31 | 261d? |  | S1; N1; N2; N4 | 10440h | 10440h | Multicall | R99 | Alain | Multicall |  |
| 8534 | 2525.7.1 | Stage 1 for Multicall | 261d? | 1999-01-01 A | 1999-12-31 A | 100% | 1999-01-01 | 1999-12-31 | 261d? | start no earlier than 1999-01-01 | S1 | 2088h | 2088h |  | R99 | Alain |  |  |
| 8535 | 2525.8 | Virtual Home Environment | 261d? | 1999-01-01 A | 1999-12-31 A | 100% | 1999-01-01 | 1999-12-31 | 261d? | start no earlier than 1999-01-01 | S1; SMG1; S2 | 6264h | 6264h | VHE | R99 | Alain | VHE |  |
| 8536 | 2525.9 | Open Service Access | 261d? | 1999-01-01 A | 1999-12-31 A | 100% | 1999-01-01 | 1999-12-31 | 261d? | start no earlier than 1999-01-01 | S1; S2; N5 | 6264h | 6264h | OSA | R99 | Alain | OSA |  |
| 8537 | 2525.10 | Super Charger mechanism for signalling traffic associated with mobility | 261d? | 1999-01-01 A | 1999-12-31 A | 100% | 1999-01-01 | 1999-12-31 | 261d? | start no earlier than 1999-01-01 | N2; N4 | 4176h | 4176h | Super_Charger | R99 | Kimmo | Super_Charger |  |
| 8538 | 2525.11 | Follow_Me service | 261d? | 1999-01-01 A | 1999-12-31 A | 100% | 1999-01-01 | 1999-12-31 | 261d? | start no earlier than 1999-01-01 | S1; N2; N4 | 6264h | 6264h | Follow_Me | R99 | Alain | Follow_Me |  |
| 8539 | 2525.12 | Wide area network Synchronization and object exchange | 261d? | 1999-01-01 A | 1999-12-31 A | 100% | 1999-01-01 | 1999-12-31 | 261d? | start no earlier than 1999-01-01 | T2 | 2088h | 2088h | SYNC | R99 |  | SYNC |  |
| 8540 | 2525.13 | **R99 Terminal Interfaces** | 261d? | 1999-01-01 A | 1999-12-31 A | 100% | 1999-01-01 | 1999-12-31 | 261d? |  | T2 | 8352h | 8352h |  | R99 |  |  |  |
| 8541 | 2525.13.1 | AT commands for 3GPP | 261d? | 1999-01-01 A | 1999-12-31 A | 100% | 1999-01-01 | 1999-12-31 | 261d? | start no earlier than 1999-01-01 | T2 | 2088h | 2088h |  | R99 |  |  |  |
| 8542 | 2525.13.2 | Physical interfaces | 261d? | 1999-01-01 A | 1999-12-31 A | 100% | 1999-01-01 | 1999-12-31 | 261d? | start no earlier than 1999-01-01 | T2 | 2088h | 2088h |  | R99 |  |  |  |
| 8543 | 2525.13.3 | Multiplexer | 261d? | 1999-01-01 A | 1999-12-31 A | 100% | 1999-01-01 | 1999-12-31 | 261d? | start no earlier than 1999-01-01 | T2 | 2088h | 2088h | MUXMS-TE | R99 |  | MUX MS-TE |  |
| 8544 | 2525.14 | **Bearer Services** | 261d? | 1999-01-01 A | 1999-12-31 A | 100% | 1999-01-01 | 1999-12-31 | 261d? |  | S1; T2; N1; N3 | 41760h | 41760h |  | R99 | Alain |  |  |
| 8545 | 2525.14.1 | **Circuit Switched Bearer Services** | 261d? | 1999-01-01 A | 1999-12-31 A | 100% | 1999-01-01 | 1999-12-31 | 261d? |  | S1; N3 | 16704h | 16704h | Circuit_switched_Bearer_Services | R99 | Alain | Circuit_switched_Bearer_Services |  |
| 8546 | 2525.14.1.1 | Stage 1 for Circuit Switched Bearer Services | 261d? | 1999-01-01 A | 1999-12-31 A | 100% | 1999-01-01 | 1999-12-31 | 261d? | start no earlier than 1999-01-01 | S1 | 2088h | 2088h | CS_Bearerss_in_UMTS | R99 | Alain | CS_Bearerss_in_UMTS |  |
| 8547 | 2525.14.1.2 | CS_Bearers | 261d? | 1999-01-01 A | 1999-12-31 A | 100% | 1999-01-01 | 1999-12-31 | 261d? | start no earlier than 1999-01-01 | N3 | 2088h | 2088h | CS_Bearers | R99 | Gwiho | CS_Bearers |  |
| 8548 | 2525.14.1.3 | CS_Bearerss | 261d? | 1999-01-01 A | 1999-12-31 A | 100% | 1999-01-01 | 1999-12-31 | 261d? | start no earlier than 1999-01-01 | N3 | 2088h | 2088h | CS_Bearerss | R99 | Gwiho | CS_Bearerss |  |
| 8549 | 2525.14.1.4 | CS_Data | 261d? | 1999-01-01 A | 1999-12-31 A | 100% | 1999-01-01 | 1999-12-31 | 261d? | start no earlier than 1999-01-01 | N3 | 2088h | 2088h | CS_Data | R99 | Gwiho | CS_Data |  |
| 8550 | 2525.14.1.5 | CS_Data_Bearers | 261d? | 1999-01-01 A | 1999-12-31 A | 100% | 1999-01-01 | 1999-12-31 | 261d? | start no earlier than 1999-01-01 | N3 | 2088h | 2088h | CS_Data_Bearers | R99 | Gwiho | CS_Data_Bearers |  |
| 8551 | 2525.14.1.6 | Deleted - CN3 poart of Circuit Switched Bearer Services | 261d? | 1999-01-01 A | 1999-12-31 A | 100% | 1999-01-01 | 1999-12-31 | 261d? | start no earlier than 1999-01-01 | N3 | 2088h | 2088h | CSBS | R99 | Gwiho | CSBS | NP-06 |
| 8552 | 2525.14.2 | Frame Tunnelling Mode | 261d? | 1999-01-01 A | 1999-12-31 A | 100% | 1999-01-01 | 1999-12-31 | 261d? | start no earlier than 1999-01-01 | T2; N1; N3 | 6264h | 6264h | FTM | R99 | Gwiho | FTM |  |
| 8553 | 2525.14.3 | Access to ISPs and Intranets – Wireless/Remote access to LANs | 261d? | 1999-01-01 A | 1999-12-31 A | 100% | 1999-01-01 | 1999-12-31 | 261d? | start no earlier than 1999-01-01 | N3 | 2088h | 2088h | InterworkingwithPDN(DHCP) | R99 | Gwiho | Interworking with PDN (DHCP) |  |
| 8554 | 2525.14.4 | **PHS Internet Access Forum Specification** | 261d? | 1999-01-01 A | 1999-12-31 A | 100% | 1999-01-01 | 1999-12-31 | 261d? |  | S1; N3 | 8352h | 8352h | PIAFS | R99 | Alain | PIAFS |  |
| 8555 | 2525.14.4.1 | Personal Handyphone System Internet Access Forum Standard (PIAFS) | 261d? | 1999-01-01 A | 1999-12-31 A | 100% | 1999-01-01 | 1999-12-31 | 261d? | start no earlier than 1999-01-01 | S1 | 2088h | 2088h |  | R99 | Alain |  |  |
| 8556 | 2525.14.4.2 | Support_of_PIAFS_in_UMTS | 261d? | 1999-01-01 A | 1999-12-31 A | 100% | 1999-01-01 | 1999-12-31 | 261d? | start no earlier than 1999-01-01 | N3 | 2088h | 2088h | Support_of_PIAFS_in_UMTS | R99 | Gwiho | Support_of_PIAFS_in_UMTS |  |

Notes:
- 8533: Multicall allows several simultaneous CS calls with dedicated bearers of independent traffic and performance characteristics. R99 Multicall was defined as a supplementary service limited to one CS bearer to be used for speech at any time. / Impacted TSs and TRs: 22.030; 22.083; 22.087; 23.008; 23.009; 23.016; 23.018; 23.108; 23.135; 24.008; 24.080; 24.135; 29.002; 29.010
- 8534: - / Impacted TSs and TRs: 22.030; 22.083; 22.087
- 8535: Information exists in SP#5-8 reports & in SP-99416,SP-000095,SP 000155. OSA allows service development by operators and 3rd parties by making use of network functionality through open, standardised, secure, extensible and scalable interfaces. / Impacted TSs and TRs: 02.01; 22.105; 22.121.23.127
- 8536: Open Service Architecture became in later Releases Open Service Access. Produced by Parlay, ETSI SPAN (TISPAN), 3GPP SA1 (Stage 1), SA2 (Stage 2) and CN5 (Stage 3), resulting in a single set of standard OSA APIs for the whole development community. / Impacted TSs and TRs: 22.121; 23.127; 29.198; 29.998
- 8537: Super Charger reduces mobility management cost by reducing the volume of location update signalling. It changes subscriber data management associated with inter-VLR and SGSN location updates. It also applies to packet services (SGSN replaces VLR and / Impacted TSs and TRs: 21.905; 23.007; 23.008; 23.012; 23.016; 23.018; 23.040; 23.060; 23.116; 23.912; 29.002
- 8538: Follow Me enables a mobile subscriber A to manipulate the Follow Me data of a party B in such a way that - under certain conditions - subsequent calls directed to party B will be forwarded to subscriber A. It is PLMN-specific and control based on USSD / Impacted TSs and TRs: 21.905; 22.004; 22.030; 22.082; 22.090; 22.094; 23.090; 24.090; 22.094; 23.011; 23.015; 23.082; 29.002
- 8539: Allows data stored in ME/USIM to be synchronized with the outside world. TS 27.103 defines protocols based upon IrMC level 4 and will evaluate new technologies (XML) for inclusion. From Rel-4 IrMC was replaced by SyncML in 27.103. / Impacted TSs and TRs: 27.103; 27.903
- 8540: -
- 8541: AT commands to control a 3G ME via an external Terminal Equipment (TE), fully compatible with GSM AT commands. R99 adds new AT commands e.g. to control Advanced Speech Call Items (ASCI) services. / Impacted TSs and TRs: 27.005; 27.007
- 8542: Conclusion: 3GPP should not produce any technical specification for terminal interfaces other than radio interface and USIM interface. SDOs could develop own optional physical connector specification based on market requirements / Impacted TSs and TRs: 27.901
- 8543: Multiplexing protocol allowing a number of simultaneous sessions between a MS and a terminal¦used to send any data (voice, SMS, USSD, fax etc.). 27.010 describes the protocol, but not the commands or data transported with it. / Impacted TSs and TRs: 27.010
- 8544: -
- 8545: CS and real-time data services provided for interworking with PSTN/ISDN so that user is unaware of access network used (UMTS, GSM or handover between ANs). Transparent(constant delay) & non-transparent(zero error with flow control) services are supported / Impacted TSs and TRs: 22.002; 23.910; 27.001; 29.007
- 8546: CS and real-time data services provided for interworking with PSTN/ISDN so that user is unaware of access network used (UMTS, GSM or handover between ANs). Transparent(constant delay) & non-transparent(zero error with flow control) services are supported / Impacted TSs and TRs: 22.002
- 8547: - / Impacted TSs and TRs: 29.007
- 8548: - / Impacted TSs and TRs: 04.21; 23.910; 27.001; 29.007
- 8549: - / Impacted TSs and TRs: 27.001; 27.002; 27.003; 29.007
- 8550: - / Impacted TSs and TRs: 23.910; 27.001; 29.007
- 8551: No CR or new TS/TR approved under this WI / Impacted TSs and TRs: 23.910; 27.001; 29.007
- 8552: FTM is a type of async non-transparent CS bearer service (22.002). Generic term for HDLC and HDLC-related transmission protocols. Converts async non-transp data stream towards mobile side & sync data stream using X.31 flag stuffing on fixed network side. / Impacted TSs and TRs: 22.002; 27.001; 27.007; 29.007
- 8553: Access to an Intranet or ISP by running DHCP between the TE and a server in the Intranet/ISP domain. / Impacted TSs and TRs: 29.061
- 8554: PIAFS is one type of CS bearer data service (22.002). It refers to async CS tx protocol over ISDN 64 kbit/s unrestricted digital line. Facilitates interworking between PHS-MS and UMTS-UE & UMTS-UE and existing PIAFS TA (Terminal Adapter). / Impacted TSs and TRs: 22.002; 27.001; 27.007; 29.007
- 8555: PIAFS was originally standardised by the PHS Internet Access Forum in Japan. More information can be found at: http://www.infopro.or.jp/piaf / Impacted TSs and TRs: 22.002
- 8556: - / Impacted TSs and TRs: 27.001; 27.007; 29.007

| ID | WBS | Task | Duration | Start | Finish | Complete | Baseline start | Baseline finish | Baseline duration | Constraint | Resources | Work | Actual work | Acronym | Release | MCC resp | Acronym_3GU_Export | TSG stopped |
| --- | --- | --- | --- | --- | --- | --- | --- | --- | --- | --- | --- | --- | --- | --- | --- | --- | --- | --- |
| 8557 | 2525.15 | **Universal Integrated Circuit Card (UICC) and Universal Subscriber Identity Module (USIM)** | 261d? | 1999-01-01 A | 1999-12-31 A | 100% | 1999-01-01 | 1999-12-31 | 261d? |  | T3 | 31320h | 31320h | UICC,USIM | R99 | Xavier | UICC, USIM |  |
| 8558 | 2525.15.1 | UICC / Terminal interface; Physical and logical characteristics | 261d? | 1999-01-01 A | 1999-12-31 A | 100% | 1999-01-01 | 1999-12-31 | 261d? | start no earlier than 1999-01-01 | T3 | 2088h | 2088h | UICC | R99 | Xavier | UICC |  |
| 8559 | 2525.15.2 | UICC/(U)SIM enhancements and interworking | 261d? | 1999-01-01 A | 1999-12-31 A | 100% | 1999-01-01 | 1999-12-31 | 261d? | start no earlier than 1999-01-01 | T3 | 2088h | 2088h | UICC99 | R99 | Xavier | UICC1 |  |
| 8560 | 2525.15.3 | Characteristics of the USIM application | 261d? | 1999-01-01 A | 1999-12-31 A | 100% | 1999-01-01 | 1999-12-31 | 261d? | start no earlier than 1999-01-01 | T3 | 2088h | 2088h | USIM | R99 | Xavier | USIM |  |
| 8561 | 2525.15.4 | UICC Application Identifiers | 261d? | 1999-01-01 A | 1999-12-31 A | 100% | 1999-01-01 | 1999-12-31 | 261d? | start no earlier than 1999-01-01 | T3 | 2088h | 2088h | AID,Application_Identifiers | R99 | Xavier | AID, Application_Identifiers |  |
| 8562 | 2525.15.5 | SIM Application Toolkit | 261d? | 1999-01-01 A | 1999-12-31 A | 100% | 1999-01-01 | 1999-12-31 | 261d? | start no earlier than 1999-01-01 | S1; T3 | 4176h | 4176h | SAT | R99 | Alain | SAT |  |
| 8563 | 2525.15.6 | USIM Application Toolkit | 261d? | 1999-01-01 A | 1999-12-31 A | 100% | 1999-01-01 | 1999-12-31 | 261d? | start no earlier than 1999-01-01 | T3 | 2088h | 2088h | USAT | R99 | Xavier | USAT |  |
| 8564 | 2525.15.7 | Bearer Independent Protocol for SAT applications to exchange data over the GSM network | 261d? | 1999-01-01 A | 1999-12-31 A | 100% | 1999-01-01 | 1999-12-31 | 261d? | start no earlier than 1999-01-01 | T3 | 2088h | 2088h | BIP | R99 | Xavier | BIP |  |
| 8565 | 2525.15.8 | Administrative commands and functions for IC cards | 261d? | 1999-01-01 A | 1999-12-31 A | 100% | 1999-01-01 | 1999-12-31 | 261d? | start no earlier than 1999-01-01 | T3 | 2088h | 2088h |  | R99 | Xavier |  |  |
| 8566 | 2525.15.9 | USIM and UICC requirements | 261d? | 1999-01-01 A | 1999-12-31 A | 100% | 1999-01-01 | 1999-12-31 | 261d? | start no earlier than 1999-01-01 | T3 | 2088h | 2088h |  | R99 | Xavier |  |  |
| 8567 | 2525.15.10 | SIM_API | 261d? | 1999-01-01 A | 1999-12-31 A | 100% | 1999-01-01 | 1999-12-31 | 261d? | start no earlier than 1999-01-01 | T3 | 2088h | 2088h | SIM_API | R99 | Xavier | SIM_API |  |
| 8568 | 2525.15.11 | SIM_toolkit_API | 261d? | 1999-01-01 A | 1999-12-31 A | 100% | 1999-01-01 | 1999-12-31 | 261d? | start no earlier than 1999-01-01 | SMG9; T3 | 4176h | 4176h | SIM_toolkit | R99 | Xavier | SIM_toolkit |  |
| 8569 | 2525.15.12 | Deleted - 1.8 Volt SIM ME interface | 261d? | 1999-01-01 A | 1999-12-31 A | 100% | 1999-01-01 | 1999-12-31 | 261d? | start no earlier than 1999-01-01 | SMG9 | 2088h | 2088h | SMIME_1.8V | R99 | Xavier | SMIME_1.8V | TP-06 |
| 8570 | 2525.16 | **USIM/UICC Testing** | 261d? | 1999-01-01 A | 1999-12-31 A | 100% | 1999-01-01 | 1999-12-31 | 261d? |  | T3 | 10440h | 10440h |  | R99 | Xavier |  |  |
| 8571 | 2525.16.1 | Terminal tests for the UICC Interface | 261d? | 1999-01-01 A | 1999-12-31 A | 100% | 1999-01-01 | 1999-12-31 | 261d? | start no earlier than 1999-01-01 | T3 | 2088h | 2088h |  | R99 | Xavier |  |  |
| 8572 | 2525.16.2 | USIM application test specification | 261d? | 1999-01-01 A | 1999-12-31 A | 100% | 1999-01-01 | 1999-12-31 | 261d? | start no earlier than 1999-01-01 | T3 | 2088h | 2088h |  | R99 | Xavier |  |  |
| 8573 | 2525.16.3 | USIM conformance test specification | 261d? | 1999-01-01 A | 1999-12-31 A | 100% | 1999-01-01 | 1999-12-31 | 261d? | start no earlier than 1999-01-01 | T3 | 2088h | 2088h |  | R99 | Xavier |  |  |
| 8574 | 2525.16.4 | SIM toolkit test specification | 261d? | 1999-01-01 A | 1999-12-31 A | 100% | 1999-01-01 | 1999-12-31 | 261d? | start no earlier than 1999-01-01 | T3 | 2088h | 2088h |  | R99 | Xavier |  |  |
| 8575 | 2525.17 | **Security for UMTS and GSM Features** | 261d? | 1999-01-01 A | 1999-12-31 A | 100% | 1999-01-01 | 1999-12-31 | 261d? |  | S3; N2; N4 | 16704h | 16704h | Security | R99 | Mirko | Security |  |
| 8576 | 2525.17.1 | Fraud Information Gathering Service (for connection-orientated services) | 261d? | 1999-01-01 A | 1999-12-31 A | 100% | 1999-01-01 | 1999-12-31 | 261d? | start no earlier than 1999-01-01 | S3 | 2088h | 2088h | FIGS | R99 | Mirko | FIGS |  |
| 8577 | 2525.17.2 | Immediate Service Termination / SECurity Immediate Service Termination | 261d? | 1999-01-01 A | 1999-12-31 A | 100% | 1999-01-01 | 1999-12-31 | 261d? | start no earlier than 1999-01-01 | S3; N2; N4 | 6264h | 6264h | IST,SECIST | R99 | Mirko | IST, SECIST |  |
| 8578 | 2525.17.3 | Core_Network_Security | 261d? | 1999-01-01 A | 1999-12-31 A | 100% | 1999-01-01 | 1999-12-31 | 261d? | start no earlier than 1999-01-01 | N4 | 2088h | 2088h | Core_Network_Security | R99 | Kimmo | Core_Network_Security |  |
| 8579 | 2526 | **GSM Features** | 261d? | 1999-01-01 A | 1999-12-31 A | 100% | 1999-01-01 | 1999-12-31 | 261d? |  | S1; S2; SMG; T2; N1; N2; N3; N4 | 164952h | 164952h |  | R99 | Alain |  |  |
| 8580 | 2526.1 | **Dual Transfer Mode within GSM and GPRS** | 261d? | 1999-01-01 A | 1999-12-31 A | 100% | 1999-01-01 | 1999-12-31 | 261d? |  | SMG; N1 | 10440h | 10440h | DTM | R99 | Frederic | DTM |  |
| 8581 | 2526.1.1 | Class A Dual Transfer Mode | 261d? | 1999-01-01 A | 1999-12-31 A | 100% | 1999-01-01 | 1999-12-31 | 261d? | start no earlier than 1999-01-01 | SMG | 2088h | 2088h | Class_A_Dual_Transfer_Mode_(DTM) | R99 | Frederic | Class_A_Dual_Transfer_Mode_(DTM) |  |
| 8582 | 2526.1.2 | Dual Transfer Mode | 261d? | 1999-01-01 A | 1999-12-31 A | 100% | 1999-01-01 | 1999-12-31 | 261d? | start no earlier than 1999-01-01 | SMG; N1 | 4176h | 4176h |  | R99 | Frederic |  |  |

Notes:
- 8557: For 3G, GSM 11.11 was divided into two parts: a platform comprised of basic physical, electrical and logical specification (31.101) and an application specification (31.102)
- 8558: Defines a generic Terminal/Integrated Circuit Card (ICC) interface. Is independent of 3G USIM application => platform for any IC card application. Ensures interoperability between ICC and terminal independently of manufacturer, card issuer or operator. / Impacted TSs and TRs: 31.101 (Since 10/2000; ETSI EP SCP is responsible for the generic Terminal/Integrated Circuit Card (ICC) interface 102 221)
- 8559: Acronym changed from UICC1 / Impacted TSs and TRs: 31.102; 31.900
- 8560: Defines Universal Subscriber Identity Module (USIM) application for 3G telecom network operation & resides on UICC, an IC card specified in 31.101. UICC can be used as a multi-application card: several USIMs and/or other applications can co-exist / Impacted TSs and TRs: 31.102
- 8561: Defines and administers Application IDentifiers (AID) for UICC. AID is used to address an application in the card. Consists of Registered application provider ID (RID) & Proprietary application ID exception (PIX - according to ISO/IEC 7816-5). / Impacted TSs and TRs: 21.111; 31.110
- 8562: - / Impacted TSs and TRs: 11.14; 22.030; 22.100; 22.101
- 8563: Defines UICC - ME interface, and mandatory ME procedures for USAT. Based on GSM 11.14 (SIM Application Toolkit). Commands and procedures defined in USIM and 3G Terminal for using USAT. Service and security requirements defined in 22.100 and 22.101. / Impacted TSs and TRs: 31.111
- 8564: Defines at SIM-ME interface a basic protocol allowing SIM Toolkit applications to determine available bearers and to exchange data by selecting using the most appropriate bearer available (CS data, GPRS, SMS, Unstructured Supplementary Service Data (USSD) / Impacted TSs and TRs: 03.48; 11.10; 11.14
- 8565: Defines function and syntax of administrative commands for telecommunication IC Card used during installation, activation and de-activation of applications. Compliant to ISO/IEC 7816 series. Handed over to ETSI Project Smart Card Platform (SCP) in 2000. / Impacted TSs and TRs: ETSI 102 222
- 8566: High level requirements for 3GPP IC card and its interface to 3GPP terminal (USIM&UICC reqs). Service&security reqs in 322.01,22.00. USIM is a 3GPP application on an IC card. Inter-operates with 3GPP terminals and provides access to 3GPP services / Impacted TSs and TRs: 21.111
- 8567: - / Impacted TSs and TRs: 03.19
- 8568: - / Impacted TSs and TRs: 03.48; 11.11; 11.14
- 8569: No CR or new TS/TR approved under this WI / Impacted TSs and TRs: 11.18
- 8570: -
- 8571: Test spec for the interface between UICC and terminal (originally based GSM 11.10-1 clause 27). Ensures UICC - terminal interoperability independently of manufacturer, card issuer or operator. Tests for applications residing on UICC are in 31.121 / Impacted TSs and TRs: 31.120
- 8572: Application test spec originally based on GSM 11.17. Aspects related to UICC administrative management phase are not defined. Any internal technical realisation of either UICC or terminal is only specified where these are reflected over the interface. / Impacted TSs and TRs: 31.121
- 8573: Conformance Test specification for UICC defined in 31.101 with USIM defined in 31.102. / Impacted TSs and TRs: 31.122
- 8574: SIM Application Toolkit (SAT) has major impact on ME design and enhances SIM/ME interface. Contains tests for SIM/ME interface optional features (no network related signalling issues involved). Doesn't form basis for any type approval or regulatory tests. / Impacted TSs and TRs: 11.10-4
- 8575: - / Impacted TSs and TRs: 02.09; 03.20; 21.133; 22.022; 23.003; 23.007; 23.008; 23.012; 23.018; 24.007; 24.008; 24.010; 24.011; 29.002; 29.060; New (33.102; 33.103; 33.105; 33.107; 35.201)
- 8576: HPLMN can monitor its subscribers in VPLMN, which collects info on a defined set of monitored subscribers activities & sends it to HPLMN, which can perform service limitation control eg Operator Determined Barring (ODB) and IST to limit financial exposure / Impacted TSs and TRs: New 22.031; 23.031
- 8577: HPLMN can terminate all activities of its subscriber in VPLMN, if decides (based on info via eg FIGS) that a roaming subscriber is behaving in fraudulent/suspicious way. HPLMN can terminate all subscriber activities including calls in progress. / Impacted TSs and TRs: 03.35; 22.032; 23.008; 23.016; 23.035; 29.002
- 8578: - / Impacted TSs and TRs: 29.002
- 8579: -
- 8580: 2-99-1780 (2-99-H80 from SMG2#32) WID on BSS co-ordination of Radio Resource allocation for class A GPRS services - GSM Radio Access (R99) / Impacted TSs and TRs: 03.55; 03.64; 04.18; 04.60; 05.01; 05.02; 05.08; 08.08; 23.060; 24.007; 24.008
- 8581: - / Impacted TSs and TRs: 05.10
- 8582: - / Impacted TSs and TRs: 03.55; 03.64; 04.18; 05.01; 05.02; 05.08; 24.008

| ID | WBS | Task | Duration | Start | Finish | Complete | Baseline start | Baseline finish | Baseline duration | Constraint | Resources | Work | Actual work | Acronym | Release | MCC resp | Acronym_3GU_Export | TSG stopped | WI rapporteur name | WI rapporteur e-mail |
| --- | --- | --- | --- | --- | --- | --- | --- | --- | --- | --- | --- | --- | --- | --- | --- | --- | --- | --- | --- | --- |
| 8583 | 2526.2 | **General Packet Radio Service enahancements** | 261d? | 1999-01-01 A | 1999-12-31 A | 100% | 1999-01-01 | 1999-12-31 | 261d? |  | S1; S2; SMG1; SMG2; SMG7; N1; N2; N3; N4; T2 | 50112h | 50112h | GPRSenhancements | R99 | Alain | GPRS enhancements |  |  |  |
| 8584 | 2526.2.1 | General Packet Radio Service | 261d? | 1999-01-01 A | 1999-12-31 A | 100% | 1999-01-01 | 1999-12-31 | 261d? | start no earlier than 1999-01-01 | S1; S2; SMG1; SMG2; SMG7; N1; N2; N3; N4; T2 | 20880h | 20880h | GPRS | R99 | Alain | GPRS |  |  |  |
| 8585 | 2526.2.2 | GPRS2 | 261d? | 1999-01-01 A | 1999-12-31 A | 100% | 1999-01-01 | 1999-12-31 | 261d? | start no earlier than 1999-01-01 | SMG1; N2 | 4176h | 4176h | GPRS2 | R99 |  | GPRS2 |  |  |  |
| 8586 | 2526.2.3 | GPRS Tunnelling Protocol enhancement | 261d? | 1999-01-01 A | 1999-12-31 A | 100% | 1999-01-01 | 1999-12-31 | 261d? | start no earlier than 1999-01-01 | N4; N2 | 4176h | 4176h | GTP_enhancement | R99 | Kimmo | GTP_enhancement |  |  |  |
| 8587 | 2526.3 | **Enhanced Data rates for GSM Evolution - Phase 1** | 261d? | 1999-01-01 A | 1999-12-31 A | 100% | 1999-01-01 | 1999-12-31 | 261d? |  | SMG2; SMG1; SMG3; SMG4; SMG7; SMG9; SMG10; N1; N3; T2 | 73080h | 73080h | EDGE-Phase1 | R99 | Maurice | EDGE - Phase 1 |  |  |  |
| 8588 | 2526.3.1 | Enhanced Data rates for GSM Evolution | 261d? | 1999-01-01 A | 1999-12-31 A | 100% | 1999-01-01 | 1999-12-31 | 261d? | start no earlier than 1999-01-01 | SMG2; SMG1; SMG3; SMG4; SMG7; SMG9; SMG10; N1; N3; T2 | 20880h | 20880h | EDGE | R99 | Maurice | EDGE |  |  |  |
| 8589 | 2526.3.2 | EDGE-Layer1 | 261d? | 1999-01-01 A | 1999-12-31 A | 100% | 1999-01-01 | 1999-12-31 | 261d? | start no earlier than 1999-01-01 | SMG2 | 2088h | 2088h | EDGE-Layer1 | R99 |  | EDGE-Layer1 |  |  |  |
| 8590 | 2526.3.3 | High Speed Circuit Switched Data | 261d? | 1999-01-01 A | 1999-12-31 A | 100% | 1999-01-01 | 1999-12-31 | 261d? | start no earlier than 1999-01-01 | SMG1; SMG2; SMG7 | 6264h | 6264h | HSCSD | R99 |  | HSCSD |  |  |  |
| 8591 | 2526.3.4 | Enhanced Circuit Switched Data - Phase 1 | 261d? | 1999-01-01 A | 1999-12-31 A | 100% | 1999-01-01 | 1999-12-31 | 261d? | start no earlier than 1999-01-01 | S1; SMG | 4176h | 4176h | ECSD | R99 | Alain | ECSD |  |  |  |
| 8592 | 2526.3.5 | EDGE-Enhanced Circuit Switched Data | 261d? | 1999-01-01 A | 1999-12-31 A | 100% | 1999-01-01 | 1999-12-31 | 261d? | start no earlier than 1999-01-01 | SMG2 | 2088h | 2088h | EDGE-ECSD | R99 |  | EDGE-ECSD |  |  |  |
| 8593 | 2526.3.6 | Enhanced GPRS - Phase 1 | 261d? | 1999-01-01 A | 1999-12-31 A | 100% | 1999-01-01 | 1999-12-31 | 261d? | start no earlier than 1999-01-01 | SMG; N1 | 4176h | 4176h | EGPRS | R99 |  | EGPRS |  |  |  |
| 8594 | 2526.3.7 | EDGE-EGPRS | 261d? | 1999-01-01 A | 1999-12-31 A | 100% | 1999-01-01 | 1999-12-31 | 261d? | start no earlier than 1999-01-01 | SMG2 | 2088h | 2088h | EDGE-EGPRS | R99 |  | EDGE-EGPRS |  |  |  |
| 8595 | 2526.3.8 | Packet Flow Context (PFC) | 261d? | 1999-01-01 A | 1999-12-31 A | 100% | 1999-01-01 | 1999-12-31 | 261d? | start no earlier than 1999-01-01 | SMG2 | 2088h | 2088h | PFC | R99 |  | PFC |  |  |  |
| 8596 | 2526.3.9 | Support for EGPRS in ANSI-136 networks and EDGE COMPACT | 261d? | 1999-01-01 A | 1999-12-31 A | 100% | 1999-01-01 | 1999-12-31 | 261d? | start no earlier than 1999-01-01 | SMG | 2088h | 2088h | EDGE-Compact | R99 |  | EDGE-Compact |  |  |  |
| 8597 | 2526.3.10 | EGPRS COMPACT | 261d? | 1999-01-01 A | 1999-12-31 A | 100% | 1999-01-01 | 1999-12-31 | 261d? | start no earlier than 1999-01-01 | SMG | 2088h | 2088h | EGPRS-Compact | R99 |  | EGPRS-Compact |  |  |  |
| 8598 | 2526.3.11 | COMPACT | 261d? | 1999-01-01 A | 1999-12-31 A | 100% | 1999-01-01 | 1999-12-31 | 261d? | start no earlier than 1999-01-01 | SMG; N1 | 4176h | 4176h | COMPACT | R99 |  | COMPACT |  |  |  |
| 8599 | 2526.4 | GSM_400 | 261d? | 1999-01-01 A | 1999-12-31 A | 100% | 1999-01-01 | 1999-12-31 | 261d? | start no earlier than 1999-01-01 | SMG2; SMG7; T2 | 6264h | 6264h | GSM_400 | R99 | Paolo | GSM_400 |  |  |  |
| 8600 | 2526.5 | GSM_450 | 261d? | 1999-01-01 A | 1999-12-31 A | 100% | 1999-01-01 | 1999-12-31 | 261d? | start no earlier than 1999-01-01 | SMG2 | 2088h | 2088h | GSM_450 | R99 |  | GSM_450 |  |  |  |
| 8601 | 2526.6 | GSM_700 | 261d? | 1999-01-01 A | 1999-12-31 A | 100% | 1999-01-01 | 1999-12-31 | 261d? | start no earlier than 1999-01-01 | SMG2 | 2088h | 2088h | GSM_700 | R99 |  | GSM_700 |  |  |  |
| 8602 | 2526.7 | Deleted - GERAN | 261d? | 1999-01-01 A | 1999-12-31 A | 100% | 1999-01-01 | 1999-12-31 | 261d? | start no earlier than 1999-01-01 | SMG2; S2 | 4176h | 4176h | GERAN | R99 | Maurice | GERAN | SP-06 |  |  |
| 8603 | 2527 | **GSM Features transposed to UMTS** | 261d? | 1999-01-01 A | 1999-12-31 A | 100% | 1999-01-01 | 1999-12-31 | 261d? |  | S1; S3; T2; N2; N4 | 31320h | 31320h |  | R99 | Alain |  |  |  |  |
| 8604 | 2527.1 | Cell Broadcast Service | 261d? | 1999-01-01 A | 1999-12-31 A | 100% | 1999-01-01 | 1999-12-31 | 261d? | start no earlier than 1999-01-01 | T2 | 2088h | 2088h | CBS | R99 |  | CBS |  |  |  |
| 8605 | 2527.2 | **GSM mobile number portability euro MNP / North American MNP** | 261d? | 1999-01-01 A | 1999-12-31 A | 100% | 1999-01-01 | 1999-12-31 | 261d? |  | S1; N2; N4 | 10440h | 10440h | MNP | R99 | Alain | MNP |  |  |  |
| 8606 | 2527.2.1 | Mobile Number Portability | 261d? | 1999-01-01 A | 1999-12-31 A | 100% | 1999-01-01 | 1999-12-31 | 261d? | start no earlier than 1999-01-01 | N2; N4 | 4176h | 4176h |  | R99 | Kimmo |  |  |  |  |
| 8607 | 2527.3 | Automatic establishment of roaming relations | 261d? | 1999-01-01 A | 1999-12-31 A | 100% | 1999-01-01 | 1999-12-31 | 261d? | start no earlier than 1999-01-01 | S1 | 2088h | 2088h |  | R99 | Alain |  |  | Telecom Italia | enrico.scarrone@telecomitalia.it |
| 8608 | 2527.4 | Advanced addressing | 261d? | 1999-01-01 A | 1999-12-31 A | 100% | 1999-01-01 | 1999-12-31 | 261d? | start no earlier than 1999-01-01 | S1 | 2088h | 2088h |  | R99 | Alain |  |  |  |  |
| 8609 | 2527.5 | UMTS numbering, addressing and identities | 261d? | 1999-01-01 A | 1999-12-31 A | 100% | 1999-01-01 | 1999-12-31 | 261d? | start no earlier than 1999-01-01 | S1 | 2088h | 2088h |  | R99 | Alain |  |  |  |  |
| 8610 | 2527.6 | Lawful Interception for GSM Features transposed to UMTS | 261d? | 1999-01-01 A | 1999-12-31 A | 100% | 1999-01-01 | 1999-12-31 | 261d? | start no earlier than 1999-01-01 | S3 | 2088h | 2088h | LI | R99 | Mirko | LI |  |  |  |

Notes:
- 8583: GPRS was introduced in Release 97. Release 99 brings a number of essential corrections e.g. on Downlink Power Control, Timing Advance procedure, Cell reselection delay time, PBCCH scheduling, PTCCH mapping, etc. / Impacted TSs and TRs: 05.02; 05.05; 05.08; 05.10; 05.50; 11.21; 23.064; 24.008; 24.060
- 8584: - / Impacted TSs and TRs: 02.60; 03.22; 03.64; 04.18; 04.60; 04.64; 04.65; 05.01; 05.02; 05.05; 05.08; 05.10; 08.08; 08.18; 11.10-1; 11.21; 22.041; 22.060; 23.003; 23.007; 23.060; 23.107; 23.122; 24.007; 24.008; 27.007; 27.060; 29.002; 29.016; 29.018; 29.060; 29.061
- 8585: Introduction of EGPRS (S1) + Introduction of Reserved Service Labels in the APN (N2) / Impacted TSs and TRs: 02.60; 23.003
- 8586: - / Impacted TSs and TRs: 23.003; 23.008; 29.060
- 8587: EDGE is independent of the frequency bands, so it can be deployed e.g. in 900 and 1900 MHz bands. The new physical layer based on 8-PSK modulation is introduced and EGPRS and ECSD facilitate the new modulation in single and multi slot constellation. / Impacted TSs and TRs: 10.59; 02.34; 02.60; 03.30; 05.10; 05.50; 11.26
- 8588: WID in SMG2 331/97, SMG 1147/97, SMG 1148/97 / Impacted TSs and TRs: 02.34; 03.10; 03.20; 03.64; 04.03; 04.04; 04.06; 04.08; 04.18; 04.21; 04.22; 04.60; 04.64; 05.01; 05.02; 05.03; 05.04; 05.05; 05.08; 05.10; 05.50; 07.01; 07.02; 07.03; 08.08; 08.20; 08.58; 08.60; 09.07; 09.18; 11.10-1; 11.11; 11.21; 11.26; 23.034; 24.008.
- 8589: WID in SMG2 331/97, SMG 1147/97, SMG 1148/97 / Impacted TSs and TRs: 05.05; 05.10; 05.50
- 8590: No additional features for R99. / Impacted TSs and TRs: 02.34; 04.18; 11.10-1
- 8591: ECSD supports both transparent and non-transparent services, up to 64 kbit/s and 57.6 kbit/s respectively. See Tdoc SMG2 670/99 ECSD Concept Evaluation for more info / Impacted TSs and TRs: 05.02; 08.58; 22.034
- 8592: - / Impacted TSs and TRs: 05.03
- 8593: - / Impacted TSs and TRs: 02.07; 03.64; 04.14; 04.18; 04.60; 05.05; 05.08; 24.008
- 8594: - / Impacted TSs and TRs: 05.03; 05.05; 05.08
- 8595: - / Impacted TSs and TRs: 04.18
- 8596: Support for EGPRS in ANSI-136 networks and EDGE Compact (for ANSI-136 networks only). COMPACT = Deployment of servicES in CP-150spectrum below 1 MHz / Impacted TSs and TRs: 03.22; 03.30; 03.64; 05.01; 05.02; 05.03; 05.05; 05.08; 05.10
- 8597: COMPACT = Deployment of servicES in CP-150spectrum below 1 MHz / Impacted TSs and TRs: 04.18; 05.02
- 8598: COMPACT = Deployment of servicES in CP-150spectrum below 1 MHz / Impacted TSs and TRs: 03.22; 04.18; 04.60; 05.08; 23.122; 24.008
- 8599: GSM in the 400 MHz bands allows to deploy GSM within frequency bands in the range 450 to 500 MHz, previously used for analogue cellular systems. See Tdoc SMG2 190/99 and 595/99 for further info. / Impacted TSs and TRs: 02.17; 03.22; 03.30; 04.04; 04.18; 04.60; 05.01; 05.02; 05.05; 05.08; 05.10; 05.50; 08.18; 08.58; 11.21; 24.008; 27.007
- 8600: - / Impacted TSs and TRs: 03.22; 03.30; 05.01; 05.05; 05.08
- 8601: - / Impacted TSs and TRs: 05.05
- 8602: No CR or new TS/TR approved under this WI / Impacted TSs and TRs: G2: 04.18 CR#A248 ; 04.60 CR#B090
- 8603: -
- 8604: Moved to CT1 at TSG-T closure. Applicability of the Cell Broadcast Service (as defined for GSM network) to 3G networks / Impacted TSs and TRs: 23.041
- 8605: R98 MNP: mobile subscriber ability to change PLMN operator within the same country whilst retaining its original MS ISDN number (MSISDN). IMSI is changed, only MSISDN is kept. R99 adds requirements for North American Service Provider Number Portability. / Impacted TSs and TRs: 22.066
- 8606: - / Impacted TSs and TRs: 23.018; 23.066; 29.002
- 8607: framework for commercial and technical interworking between UMTS Home Environments and Serving Networks who have no direct prior commercial agreements with each other. / Impacted TSs and TRs: 22.101; 22.971
- 8608: - / Impacted TSs and TRs: 22.101; 22.75U; 22.975
- 8609: Also new requirements for Single and Multiple Numbering scheme was added (CR#20 and 21). Deleted the term International Mobile User Identifier (IMUI) and changed IMSI (International Mobile Station Identifier=>International Mobile Subscriber Identity. / Impacted TSs and TRs: 22.101
- 8610: Defines an interception system in UMTS that supports a number of regional interception regulations. Regional interception requirements shall be met in using specific (regional) mediation functions allowing only required information to be transported. / Impacted TSs and TRs: New 33.106; 33.107

| ID | WBS | Task | Duration | Start | Finish | Complete | Baseline start | Baseline finish | Baseline duration | Constraint | Resources | Work | Actual work | Release | MCC resp | Acronym | Acronym_3GU_Export | TSG stopped |
| --- | --- | --- | --- | --- | --- | --- | --- | --- | --- | --- | --- | --- | --- | --- | --- | --- | --- | --- |
| 8611 | 2528 | **Charging** | 261d? | 1999-01-01 A | 1999-12-31 A | 100% | 1999-01-01 | 1999-12-31 | 261d? |  | S1; S5 | 8352h | 8352h | R99 | Alain |  |  |  |
| 8612 | 2528.1 | R99 Charging | 261d? | 1999-01-01 A | 1999-12-31 A | 100% | 1999-01-01 | 1999-12-31 | 261d? | start no earlier than 1999-01-01 | S1 | 2088h | 2088h | R99 | Alain | Charging | Charging |  |
| 8613 | 2528.2 | R99 OAM Charging Management | 261d? | 1999-01-01 A | 1999-12-31 A | 100% | 1999-01-01 | 1999-12-31 | 261d? | start no earlier than 1999-01-01 | S5 | 2088h | 2088h | R99 | Mirko | OAMCH,CH | OAMCH, CH |  |
| 8614 | 2529 | **Operations, Administration, Maintenance and Provisioning (OAM&P)** | 261d? | 1999-01-01 A | 1999-12-31 A | 100% | 1999-01-01 | 1999-12-31 | 261d? |  | S5 | 12528h | 12528h | R99 | Mirko | OAM1999 | OAM1999 |  |
| 8615 | 2529.1 | OAM Principles and High-level Requirements | 261d? | 1999-01-01 A | 1999-12-31 A | 100% | 1999-01-01 | 1999-12-31 | 261d? | start no earlier than 1999-01-01 | S5 | 2088h | 2088h | R99 | Mirko | PR,Princs_&_Reqs_(PR) | PR, Princs_&_Reqs_(PR) |  |
| 8616 | 2529.2 | OAM Architecture | 261d? | 1999-01-01 A | 1999-12-31 A | 100% | 1999-01-01 | 1999-12-31 | 261d? | start no earlier than 1999-01-01 | S5 | 2088h | 2088h | R99 | Mirko | OAMAR,AR,Telecom_Management_Arch_(AR) | OAMAR, AR, Telecom_Management_Arch_(AR) |  |
| 8617 | 2529.3 | OAM Configuration Management | 261d? | 1999-01-01 A | 1999-12-31 A | 100% | 1999-01-01 | 1999-12-31 | 261d? | start no earlier than 1999-01-01 | S5 | 2088h | 2088h | R99 | Mirko | OAMCM,CM | OAMCM, CM |  |
| 8618 | 2529.4 | OAM Fault Management | 261d? | 1999-01-01 A | 1999-12-31 A | 100% | 1999-01-01 | 1999-12-31 | 261d? | start no earlier than 1999-01-01 | S5 | 2088h | 2088h | R99 | Mirko | OAMFM | OAMFM |  |
| 8619 | 2529.5 | OAM Performance Management | 261d? | 1999-01-01 A | 1999-12-31 A | 100% | 1999-01-01 | 1999-12-31 | 261d? | start no earlier than 1999-01-01 | S5 | 2088h | 2088h | R99 | Mirko | OAMPM,PM | OAMPM, PM |  |
| 8620 | 2530 | Vocabulary | 261d? | 1999-01-01 A | 1999-12-31 A | 100% | 1999-01-01 | 1999-12-31 | 261d? | start no earlier than 1999-01-01 | S1 | 2088h | 2088h | R99 | Alain | Vocabulary | Vocabulary |  |
| 8621 | 2531 | Emergency | 261d? | 1999-01-01 A | 1999-12-31 A | 100% | 1999-01-01 | 1999-12-31 | 261d? | start no earlier than 1999-01-01 | S1 | 2088h | 2088h | R99 | Alain | Emergency | Emergency |  |
| 8622 | 2532 | GSM General Bearer Services (GBS) and interworking scenarios support in UMTS | 261d? | 1999-01-01 A | 1999-12-31 A | 100% | 1999-01-01 | 1999-12-31 | 261d? | start no earlier than 1999-01-01 | S1 | 2088h | 2088h | R99 | Alain | GSM_to_UMTS_Evol | GSM_to_UMTS_Evol |  |
| 8623 | 2533 | GPRS_Mobile_IP_interworking | 261d? | 1999-01-01 A | 1999-12-31 A | 100% | 1999-01-01 | 1999-12-31 | 261d? | start no earlier than 1999-01-01 | N3 | 2088h | 2088h | R99 |  | GPRS_Mobile_IP_interworking | GPRS_Mobile_IP_interworking |  |
| 8624 | 2534 | GSM/UMTS interworking | 261d? | 1999-01-01 A | 1999-12-31 A | 100% | 1999-01-01 | 1999-12-31 | 261d? | start no earlier than 1999-01-01 | N1; N2; N4; R3; S1; SMG | 12528h | 12528h | R99 | Frederic | 2G3Ginterworking | 2G3Ginterworking |  |
| 8625 | 2535 | Handover | 261d? | 1999-01-01 A | 1999-12-31 A | 100% | 1999-01-01 | 1999-12-31 | 261d? | start no earlier than 1999-01-01 | S1; SMG2; N1; N2; N4 | 10440h | 10440h | R99 | Alain | Handover | Handover |  |
| 8626 | 2536 | 2G3Ghandover | 261d? | 1999-01-01 A | 1999-12-31 A | 100% | 1999-01-01 | 1999-12-31 | 261d? | start no earlier than 1999-01-01 | SMG2 | 2088h | 2088h | R99 |  | 2G3Ghandover | 2G3Ghandover |  |
| 8627 | 2537 | Service Provider Name Indication | 261d? | 1999-01-01 A | 1999-12-31 A | 100% | 1999-01-01 | 1999-12-31 | 261d? | start no earlier than 1999-01-01 | S1 | 2088h | 2088h | R99 | Alain | SPANME | SPANME |  |
| 8628 | 2538 | Data & Data_CleanUp | 261d? | 1999-01-01 A | 1999-12-31 A | 100% | 1999-01-01 | 1999-12-31 | 261d? | start no earlier than 1999-01-01 | SMG1 | 2088h | 2088h | R99 |  | Data,Data_CleanUp | Data, Data_CleanUp |  |
| 8629 | 2539 | Unstructured Supplementary Service Data (USSD) | 261d? | 1999-01-01 A | 1999-12-31 A | 100% | 1999-01-01 | 1999-12-31 | 261d? | start no earlier than 1999-01-01 | SMG1; N4 | 4176h | 4176h | R99 | Kimmo | USSD | USSD |  |
| 8630 | 2540 | Man-Machine Interface (MMI) of the User Equipment (UE) | 261d? | 1999-01-01 A | 1999-12-31 A | 100% | 1999-01-01 | 1999-12-31 | 261d? | start no earlier than 1999-01-01 | S1 | 2088h | 2088h | R99 | Alain | MMI | MMI |  |
| 8631 | 2541 | Network Identity and Timezone (NITZ) | 261d? | 1999-01-01 A | 1999-12-31 A | 100% | 1999-01-01 | 1999-12-31 | 261d? | start no earlier than 1999-01-01 | SMG1; SMG3 | 4176h | 4176h | R99 | Alain | NITZ | NITZ |  |
| 8632 | 2542 | Deleted - Operator Determined Barring for Packet Oriented Services | 261d? | 1999-01-01 A | 1999-12-31 A | 100% | 1999-01-01 | 1999-12-31 | 261d? | start no earlier than 1999-01-01 | S1 | 2088h | 2088h | R99 | Alain | ODB_Enh. | ODB_Enh. | SP-69 |
| 8633 | 2543 | Packet Flow Management | 261d? | 1999-01-01 A | 1999-12-31 A | 100% | 1999-01-01 | 1999-12-31 | 261d? | start no earlier than 1999-01-01 | SMG2 | 2088h | 2088h | R99 |  | Packet_Flow_Management | Packet_Flow_Management |  |
| 8634 | 2544 | GPRS_Point-To-Multipoint Group call | 261d? | 1999-01-01 A | 1999-12-31 A | 100% | 1999-01-01 | 1999-12-31 | 261d? | start no earlier than 1999-01-01 | SMG1 | 2088h | 2088h | R99 |  | GPRS_PTMG | GPRS_PTMG |  |

Notes:
- 8611: -
- 8612: - / Impacted TSs and TRs: 22.115; 23.121
- 8613: - / Impacted TSs and TRs: 32.005; 32.015
- 8614: -
- 8615: - / Impacted TSs and TRs: 32.101
- 8616: - / Impacted TSs and TRs: 32.101; 32.102
- 8617: - / Impacted TSs and TRs: 32.106; 32.106-1; 32.106-2; 32.106-3; 32.106-4; 32.106-5; 32.106-6; 32.106-7; 32.106-8
- 8618: - / Impacted TSs and TRs: 32.111; 32.111-1; 32.111-2; 32.111-3; 32.111-4
- 8619: - / Impacted TSs and TRs: 12.04; 32.104
- 8620: - / Impacted TSs and TRs: 21.905
- 8621: - / Impacted TSs and TRs: 22.101
- 8622: UMTS shall support GSM General Bearer Services (GBS) and interworking scenarios as specified in 02.02 / Impacted TSs and TRs: 22.105
- 8623: - / Impacted TSs and TRs: 29.061
- 8624: - / Impacted TSs and TRs: 03.22; 04.18; 04.60; 05.02; 05.08; 05.10; 08.08; 08.18; 08.58; 09.08; 22.011; 23.003; 23.009; 23.014; 23.034; 23.122; 24.007; 24.008; 24.011; 24.080; 29.108
- 8625: - / Impacted TSs and TRs: 04.18; 08.08; 08.58; 22.129; 23.009; 29.002; 29.010
- 8626: - / Impacted TSs and TRs: 04.18; 04.60; 05.02; 05.08; 05.10; 08.08; 29.010
- 8627: Service Provider Name Indication included in R98 (02.07) was not carried into R99 (22.101), but is in the SIM/USIM specification for R99 / Impacted TSs and TRs: 22.101
- 8628: - / Impacted TSs and TRs: 02.01; 02.02; 02.04; 02.34
- 8629: No additional features for R99. / Impacted TSs and TRs: 02.04; 02.90; 23.090; 29.002
- 8630: Data services streamlining + Support for Anonymous Call Rejection / Impacted TSs and TRs: 22.030
- 8631: - / Impacted TSs and TRs: 02.42; 04.08
- 8632: Remove ODB for Packet Oriented Services from R99 / Impacted TSs and TRs: 22.041
- 8633: - / Impacted TSs and TRs: 08.18
- 8634: - / Impacted TSs and TRs: 02.60

| ID | WBS | Task | Duration | Start | Finish | Complete | Baseline start | Baseline finish | Baseline duration | Constraint | Resources | Work | Actual work | Release | MCC resp | Acronym | Acronym_3GU_Export |
| --- | --- | --- | --- | --- | --- | --- | --- | --- | --- | --- | --- | --- | --- | --- | --- | --- | --- |
| 8635 | 2545 | **Call Forwarding** | 261d? | 1999-01-01 A | 1999-12-31 A | 100% | 1999-01-01 | 1999-12-31 | 261d? |  | SMG1; N2; N4 | 16704h | 16704h | R99 | Kimmo |  |  |
| 8636 | 2545.1 | Call Forwarding enhancements | 261d? | 1999-01-01 A | 1999-12-31 A | 100% | 1999-01-01 | 1999-12-31 | 261d? | start no earlier than 1999-01-01 | N4; N2 | 4176h | 4176h | R99 | Kimmo | CF_enhancements | CF_enhancements |
| 8637 | 2545.2 | Call_Forwarding | 261d? | 1999-01-01 A | 1999-12-31 A | 100% | 1999-01-01 | 1999-12-31 | 261d? | start no earlier than 1999-01-01 | SMG1; N2 | 4176h | 4176h | R99 | Kimmo | Call_Forwarding | Call_Forwarding |
| 8638 | 2545.3 | Call_Forwarding_Enhancements | 261d? | 1999-01-01 A | 1999-12-31 A | 100% | 1999-01-01 | 1999-12-31 | 261d? | start no earlier than 1999-01-01 | N4 | 2088h | 2088h | R99 | Kimmo | Call_Forwarding_Enhancements | Call_Forwarding_Enhancements |
| 8639 | 2546 | **Quality of Service** | 261d? | 1999-01-01 A | 1999-12-31 A | 100% | 1999-01-01 | 1999-12-31 | 261d? |  | S2; T2; N1; N2; N4 | 31320h | 31320h | R99 | Maurice |  |  |
| 8640 | 2546.1 | End-to-end UMTS Quality of Service management | 261d? | 1999-01-01 A | 1999-12-31 A | 100% | 1999-01-01 | 1999-12-31 | 261d? | start no earlier than 1999-01-01 | S2; T2; N1; N2; N4 | 10440h | 10440h | R99 | Maurice | QoS | QoS |
| 8641 | 2546.2 | End-to-end QoS for PS Domain including IMS | 261d? | 1999-01-01 A | 1999-12-31 A | 100% | 1999-01-01 | 1999-12-31 | 261d? | start no earlier than 1999-01-01 | S2 | 2088h | 2088h | R99 | Maurice | E2EQoS99 | E2EQoS |
| 8642 | 2546.3 | GPRS-enhanced_QoS | 261d? | 1999-01-01 A | 1999-12-31 A | 100% | 1999-01-01 | 1999-12-31 | 261d? | start no earlier than 1999-01-01 | T2 | 2088h | 2088h | R99 |  | GPRS-enhanced_QoS | GPRS-enhanced_QoS |
| 8643 | 2546.4 | QoS_enhancements | 261d? | 1999-01-01 A | 1999-12-31 A | 100% | 1999-01-01 | 1999-12-31 | 261d? | start no earlier than 1999-01-01 | N2; N1; N4 | 6264h | 6264h | R99 | Kimmo | QoS_enhancements | QoS_enhancements |
| 8644 | 2547 | Support of Localised Service Area | 261d? | 1999-01-01 A | 1999-12-31 A | 100% | 1999-01-01 | 1999-12-31 | 261d? | start no earlier than 1999-01-01 | SMG2; SMG3; SMG7; N2 | 8352h | 8352h | R99 | Maurice | SoLSA | SoLSA |
| 8645 | 2548 | Transcoder_location | 261d? | 1999-01-01 A | 1999-12-31 A | 100% | 1999-01-01 | 1999-12-31 | 261d? | start no earlier than 1999-01-01 | S2 | 2088h | 2088h | R99 | Maurice | Transcoder_location | Transcoder_location |
| 8646 | 2549 | Antenna_test_methods | 261d? | 1999-01-01 A | 1999-12-31 A | 100% | 1999-01-01 | 1999-12-31 | 261d? | start no earlier than 1999-01-01 | SMG2 | 2088h | 2088h | R99 |  | Antenna_test_methods | Antenna_test_methods |
| 8647 | 2550 | WBAMR / high quality speech in UMTS Phase 1 but not in R99 | 261d? | 1999-01-01 A | 1999-12-31 A | 100% | 1999-01-01 | 1999-12-31 | 261d? | start no earlier than 1999-01-01 | S1 | 2088h | 2088h | R99 | Alain | WBAMR | WBAMR |
| 8648 | 2551 | **Codec** | 261d? | 1999-01-01 A | 1999-12-31 A | 100% | 1999-01-01 | 1999-12-31 | 261d? |  | S4 | 27144h | 27144h | R99 | Paolo |  |  |
| 8649 | 2551.1 | **Codecs for Multimedia Telephony Service** | 261d? | 1999-01-01 A | 1999-12-31 A | 100% | 1999-01-01 | 1999-12-31 | 261d? |  | S4 | 14616h | 14616h | R99 | Paolo | Codec_for_Multimedia_Telephony | Codec_for_Multimedia_Telephony |
| 8650 | 2551.1.1 | Codecs for Multimedia Telephony Service | 261d? | 1999-01-01 A | 1999-12-31 A | 100% | 1999-01-01 | 1999-12-31 | 261d? | start no earlier than 1999-01-01 | S4 | 2088h | 2088h | R99 | Paolo | Multimedia_Codec | Multimedia_Codec |
| 8651 | 2551.1.2 | Codecs for Multimedia Telephony Service | 261d? | 1999-01-01 A | 1999-12-31 A | 100% | 1999-01-01 | 1999-12-31 | 261d? | start no earlier than 1999-01-01 | S4 | 2088h | 2088h | R99 | Paolo | CSM | CSM |
| 8652 | 2551.1.3 | Codecs for Multimedia Telephony Service | 261d? | 1999-01-01 A | 1999-12-31 A | 100% | 1999-01-01 | 1999-12-31 | 261d? | start no earlier than 1999-01-01 | S4 | 2088h | 2088h | R99 | Paolo | WI2MMC | WI2MMC |
| 8653 | 2551.1.4 | Codecs for Multimedia Telephony Service | 261d? | 1999-01-01 A | 1999-12-31 A | 100% | 1999-01-01 | 1999-12-31 | 261d? | start no earlier than 1999-01-01 | S4 | 2088h | 2088h | R99 | Paolo | Codec(s)_for_CS_MM_Tel._Serv | Codec(s)_for_CS_MM_Tel._Serv |
| 8654 | 2551.1.5 | Codecs for Multimedia Telephony Service | 261d? | 1999-01-01 A | 1999-12-31 A | 100% | 1999-01-01 | 1999-12-31 | 261d? | start no earlier than 1999-01-01 | S4 | 2088h | 2088h | R99 | Paolo | Codec(s)_for_MM_Tel_Service | Codec(s)_for_MM_Tel_Service |
| 8655 | 2551.1.6 | Codecs for Multimedia Telephony Service | 261d? | 1999-01-01 A | 1999-12-31 A | 100% | 1999-01-01 | 1999-12-31 | 261d? | start no earlier than 1999-01-01 | S4 | 2088h | 2088h | R99 | Paolo |  |  |
| 8656 | 2551.2 | QoS for Speech and Multimedia Codec | 261d? | 1999-01-01 A | 1999-12-31 A | 100% | 1999-01-01 | 1999-12-31 | 261d? | start no earlier than 1999-01-01 | S4 | 2088h | 2088h | R99 | Paolo | QoS_for_Speech_&_MM_Codecs_/_AMR | QoS_for_Speech_&_MM_Codecs_/_AMR |
| 8657 | 2551.3 | Tandem Free Operation - Adaptive Multi-Rate codec types | 261d? | 1999-01-01 A | 1999-12-31 A | 100% | 1999-01-01 | 1999-12-31 | 261d? | start no earlier than 1999-01-01 | S4 | 2088h | 2088h | R99 | Paolo | TFOAMR | TFOAMR |
| 8658 | 2551.4 | Noise Suppression for AMR | 261d? | 1999-01-01 A | 1999-12-31 A | 100% | 1999-01-01 | 1999-12-31 | 261d? | start no earlier than 1999-01-01 | S4 | 2088h | 2088h | R99 | Paolo | AMRNS | AMRNS |
| 8659 | 2551.5 | Out-of-Band Transcoder | 261d? | 1999-01-01 A | 1999-12-31 A | 100% | 1999-01-01 | 1999-12-31 | 261d? | start no earlier than 1999-01-01 | N1 | 2088h | 2088h | R99 | Frederic | OoBT | OoBT |
| 8660 | 2551.6 | Out-of-Band Transcoder Control | 261d? | 1999-01-01 A | 1999-12-31 A | 100% | 1999-01-01 | 1999-12-31 | 261d? | start no earlier than 1999-01-01 | N1 | 2088h | 2088h | R99 | Frederic | OoBTC | OoBTC |
| 8661 | 2552 | Advanced Speech Call Items enhancements | 261d? | 1999-01-01 A | 1999-12-31 A | 100% | 1999-01-01 | 1999-12-31 | 261d? | start no earlier than 1999-01-01 | SMG1; SMG2; SMG3; SMG7; SMG9; N1; N4; S1; T2 | 18792h | 18792h | R99 | Alain | ASCI | ASCI |
| 8662 | 2553 | Call Control improvements | 261d? | 1999-01-01 A | 1999-12-31 A | 100% | 1999-01-01 | 1999-12-31 | 261d? | start no earlier than 1999-01-01 | N1 | 2088h | 2088h | R99 | Frederic | CC_Related_items | CC_Related_items |
| 8663 | 2554 | Multimedia | 261d? | 1999-01-01 A | 1999-12-31 A | 100% | 1999-01-01 | 1999-12-31 | 261d? | start no earlier than 1999-01-01 | N1; N3 | 4176h | 4176h | R99 | Frederic | Multimedia | Multimedia |
| 8664 | 2555 | Sub-System Number allocation for RANAP, RNSAP | 261d? | 1999-01-01 A | 1999-12-31 A | 100% | 1999-01-01 | 1999-12-31 | 261d? | start no earlier than 1999-01-01 | N2 | 2088h | 2088h | R99 | Frederic | SSN_allocation | SSN_allocation |
| 8665 | 2556 | Intranet / ISP access with DHCP end-to-end | 261d? | 1999-01-01 A | 1999-12-31 A | 100% | 1999-01-01 | 1999-12-31 | 261d? | start no earlier than 1999-01-01 | N3 | 2088h | 2088h | R99 | Gwiho | ISPaccess | ISPaccess |
| 8666 | 2557 | Point_to_Multipoint_Services | 261d? | 1999-01-01 A | 1999-12-31 A | 100% | 1999-01-01 | 1999-12-31 | 261d? | start no earlier than 1999-01-01 | N3 | 2088h | 2088h | R99 | Gwiho | Point_to_Multipoint_Services | Point_to_Multipoint_Services |
| 8667 | 2558 | Facsimile | 261d? | 1999-01-01 A | 1999-12-31 A | 100% | 1999-01-01 | 1999-12-31 | 261d? | start no earlier than 1999-01-01 | S1 | 2088h | 2088h | R99 | Alain | FAX | FAX |
| 8668 | 2559 | Realtime_NT_FAX_in_UMTS | 261d? | 1999-01-01 A | 1999-12-31 A | 100% | 1999-01-01 | 1999-12-31 | 261d? | start no earlier than 1999-01-01 | N3 | 2088h | 2088h | R99 | Gwiho | Realtime_NT_FAX_in_UMTS | Realtime_NT_FAX_in_UMTS |
| 8669 | 2560 | Gateway Location Register (GLR) - Mobile Application Part (MAP) specification | 261d? | 1999-01-01 A | 1999-12-31 A | 100% | 1999-01-01 | 1999-12-31 | 261d? | start no earlier than 1999-01-01 | N4 | 2088h | 2088h | R99 | Kimmo | GLR | GLR |
| 8670 | 2561 | Multiple Subscriber Profile phase 2 | 261d? | 1999-01-01 A | 1999-12-31 A | 100% | 1999-01-01 | 1999-12-31 | 261d? | start no earlier than 1999-01-01 | S1; N4 | 4176h | 4176h | R99 | Alain | MSP2 | MSP2 |
| 8671 | 2562 | Prepaging | 261d? | 1999-01-01 A | 1999-12-31 A | 100% | 1999-01-01 | 1999-12-31 | 261d? | start no earlier than 1999-01-01 | N2; N4 | 4176h | 4176h | R99 | Kimmo | Prepaging | Prepaging |
| 8672 | 2563 | Re-definition of channel quality measure used for AMR link adaptation for Downlink Advanced Receiver Performance (DARP) MS | 261d? | 1999-01-01 A | 1999-12-31 A | 100% | 1999-01-01 | 1999-12-31 | 261d? | start no earlier than 1999-01-01 | SMG | 2088h | 2088h | R99 |  |  |  |
| 8673 | 2564 | Harmonized Standard | 261d? | 1999-01-01 A | 1999-12-31 A | 100% | 1999-01-01 | 1999-12-31 | 261d? | start no earlier than 1999-01-01 | SMG2 | 2088h | 2088h | R99 |  | HS | HS |
| 8674 | 2565 | Streamlining of specifications | 261d? | 1999-01-01 A | 1999-12-31 A | 100% | 1999-01-01 | 1999-12-31 | 261d? | start no earlier than 1999-01-01 | N3 | 2088h | 2088h | R99 | Gwiho | Streamlining | Streamlining |
| 8675 | 2566 | R99_Service_Clean_up | 261d? | 1999-01-01 A | 1999-12-31 A | 100% | 1999-01-01 | 1999-12-31 | 261d? | start no earlier than 1999-01-01 | N3 | 2088h | 2088h | R99 | Gwiho | R99_Service_Clean_up | R99_Service_Clean_up |

Notes:
- 8635: -
- 8636: No additional features for R99. / Impacted TSs and TRs: 23.078; 23.079; 23.082; 29.002; 29.078
- 8637: - / Impacted TSs and TRs: 02.82; 29.002
- 8638: - / Impacted TSs and TRs: 23.082
- 8639: WID SMG 98-0781 End To End UMTS QoS Management
- 8640: WID SMG 98-0781 End To End UMTS QoS Management / Impacted TSs and TRs: 23.107; 23.907; 24.008
- 8641: Acronym changed from E2EQos / Impacted TSs and TRs: 23.060; 23.170
- 8642: AT-commands for Enhanced QoS Support management / Impacted TSs and TRs: 27.007
- 8643: - / Impacted TSs and TRs: 23.008; 23.016; 24.008; 29.002; 29.060
- 8644: Mechanism which can be used as a platform for providing special tariffs and/or special set of service features for certain subscribers within a regionally restricted area or areas. No additional features for R99. / Impacted TSs and TRs: 04.08; 04.18; 08.08; 11.10-1; 29.002
- 8645: UE location identification: background information and associated primitives 2. Transcoder location at the core network and source depending coding belonging to the non-access stratum. / Impacted TSs and TRs: 23.110
- 8646: - / Impacted TSs and TRs: 03.30
- 8647: Add requirement for high quality speech in UMTS Phase 1 but not in R99 / Impacted TSs and TRs: 22.105
- 8648: -
- 8649: -
- 8650: - / Impacted TSs and TRs: 26.911; 26.104; 26.111
- 8651: - / Impacted TSs and TRs: 26.911; 26.104; 26.111
- 8652: - / Impacted TSs and TRs: 26.911; 26.104; 26.111
- 8653: - / Impacted TSs and TRs: 26.911; 26.104; 26.111
- 8654: - / Impacted TSs and TRs: 26.911; 26.104; 26.111
- 8655: - / Impacted TSs and TRs: 26.911; 26.104; 26.111
- 8656: - / Impacted TSs and TRs: 26.102; 26.912
- 8657: UMTS_AMR2 is default Codec Type in R99 dual_mode terminals / Impacted TSs and TRs: 26.103
- 8658: Combination of the AMR speech codec and the Noise Suppression function. TS 06.77 and TR 06.78 only apply to GSM. They apply to UMTS from Rel-4 onwards, when they were converted to TS 26.077 and TR 26.078. / Impacted TSs and TRs: 06.77; 06.78
- 8659: Transcoder handling in the CN at inter-system handover and relocation + Introduction of UMTS AMR / Impacted TSs and TRs: 23.009; 24.008
- 8660: 24.008 CR#0572 in NP-020220 was approved under this WI / Impacted TSs and TRs: 24.008 CR#0572 in NP-020220
- 8661: - / Impacted TSs and TRs: 02.30; 02.68; 03.68; 03.69; 04.18; 08.08; 11.10-1; 11.11; 23.067; 23.094; 24.008; 24.067; 27.007; 29.002
- 8662: Minor improvements to 24.007 and 24.008 to increase the number of simultaneous calls/sessions from the present 7: the TI value is increased (NP-99441). / Impacted TSs and TRs: 24.007; 24.008
- 8663: - / Impacted TSs and TRs: 24.008; 27.001; 29.007
- 8664: Sub-System Number allocation for Radio Access Network Application Part, Radio Network Subsystem Application Part / Impacted TSs and TRs: 23.003
- 8665: Access to an Intranet/ISP with DHCP end to end / Impacted TSs and TRs: 29.061
- 8666: Support for the IP-Multicast protocol / Impacted TSs and TRs: 29.061
- 8667: - / Impacted TSs and TRs: 22.003; 22.100
- 8668: Asynchronous Interface for real-time NT Fax + Introduction of Asynchronous interface for Real-time non-transparent FAX / Impacted TSs and TRs: 27.001; 27.003
- 8669: - / Impacted TSs and TRs: 29.120
- 8670: - / Impacted TSs and TRs: 22.097; 23.072; 23.083; 23.084; 23.091; 23.093; 23.097
- 8671: - / Impacted TSs and TRs: 23.018; 23.082; 29.002
- 8672: Re-definition of channel quality measure used for AMR link adaptation for DARP MS / Impacted TSs and TRs: 05.09
- 8673: - / Impacted TSs and TRs: 13.21
- 8674: - / Impacted TSs and TRs: 27.060; 29.061
- 8675: - / Impacted TSs and TRs: 03.10; 27.001; 27.002; 27.003; 27.060; 29.007; 29.061

| ID | WBS | Task | Type | Duration | Start | Finish | Complete | Baseline start | Baseline finish | Baseline duration | Constraint | Resources | Work | Actual work | Acronym | Release | MCC resp | Acronym_3GU_Export | Impacted TSs and TRs | TSG stopped | WI rapporteur name | WI rapporteur e-mail |
| --- | --- | --- | --- | --- | --- | --- | --- | --- | --- | --- | --- | --- | --- | --- | --- | --- | --- | --- | --- | --- | --- | --- |
| 8676 | 2567 | **(Small) Technical Enhancements and Improvements for R99** |  | 261d? | 1999-01-01 A | 1999-12-31 A | 100% | 1999-01-01 | 1999-12-31 | 261d? |  | N3 | 6264h | 6264h | TEI | R99 | Gwiho | TEI |  |  |  |  |
| 8677 | 2567.1 | TEI_[CS_Data] |  | 261d? | 1999-01-01 A | 1999-12-31 A | 100% | 1999-01-01 | 1999-12-31 | 261d? | start no earlier than 1999-01-01 | N3 | 2088h | 2088h | TEI_[CS_Data] | R99 | Gwiho | TEI_[CS_Data] |  |  |  |  |
| 8678 | 2567.2 | TEI_[GPRS] |  | 261d? | 1999-01-01 A | 1999-12-31 A | 100% | 1999-01-01 | 1999-12-31 | 261d? | start no earlier than 1999-01-01 | N3 | 2088h | 2088h | TEI_[GPRS] | R99 | Gwiho | TEI_[GPRS] |  |  |  |  |
| 8679 | 2568 | **R99 UE Conformance Testing** |  | 261d? | 1999-01-01 A | 1999-12-31 A | 100% | 1999-01-01 | 1999-12-31 | 261d? |  | R5; T1 | 6264h | 6264h | TEI_Test | R99 | Ingbert | TEI_Test | 34.108; 34.121; 34.122; 34.123-1; 34.123-2; 34.123-3 |  |  |  |
| 8680 | 2568.1 | Deleted - RTEI |  | 261d? | 1999-01-01 A | 1999-12-31 A | 100% | 1999-01-01 | 1999-12-31 | 261d? | start no earlier than 1999-01-01 | T1 | 2088h | 2088h | RTEI | R99 | Ingbert | RTEI | 34.123-1 CR#0650; 0651; 34.123-3 CR#0148; 0149; 0150 | TP-06 |  |  |
| 8681 | 2568.2 | Common test environments for User Equipment (UE); Conformance testing | milestone | 0d? | 1999-01-01 A | 1999-01-01 A | 100% | 1999-01-01 | 1999-01-01 | 0d? | start no earlier than 1999-01-01 | R5; T1 |  |  |  | R99 | Ingbert |  | 34.108 |  |  |  |
| 8682 | 2568.3 | Terminal conformance specification, Radio transmission and reception (FDD) | milestone | 0d? | 1999-01-01 A | 1999-01-01 A | 100% | 1999-01-01 | 1999-01-01 | 0d? | start no earlier than 1999-01-01 | R5; T1 |  |  |  | R99 | Ingbert |  | 34.121 |  |  |  |
| 8683 | 2568.4 | Terminal conformance specification, Radio transmission and reception (TDD) | milestone | 0d? | 1999-01-01 A | 1999-01-01 A | 100% | 1999-01-01 | 1999-01-01 | 0d? | start no earlier than 1999-01-01 | R5; T1 |  |  |  | R99 | Ingbert |  | 34.122 |  |  |  |
| 8684 | 2568.5 | UE conformance specification; Part 1: Protocol conformance specification | milestone | 0d? | 1999-01-01 A | 1999-01-01 A | 100% | 1999-01-01 | 1999-01-01 | 0d? | start no earlier than 1999-01-01 | R5; T1 |  |  |  | R99 | Ingbert |  | 34.123-1 |  |  |  |
| 8685 | 2568.6 | UE conformance specification; Part 2: Implementation Conformance Statement (ICS) specification | milestone | 0d? | 1999-01-01 A | 1999-01-01 A | 100% | 1999-01-01 | 1999-01-01 | 0d? | start no earlier than 1999-01-01 | R5; T1 |  |  |  | R99 | Ingbert |  | 34.123-2 |  |  |  |
| 8686 | 2568.7 | UE conformance specification; Part 3: Abstract test suites (ATSs) | milestone | 0d? | 1999-01-01 A | 1999-01-01 A | 100% | 1999-01-01 | 1999-01-01 | 0d? | start no earlier than 1999-01-01 | R5; T1 |  |  |  | R99 | Ingbert |  | 34.123-3 |  |  |  |
| 8687 | 2569 | Deleted - Dual Tone Multi-Frequency signalling : Support in the whole 3GPP system |  | 261d? | 1999-01-01 A | 1999-12-31 A | 100% | 1999-01-01 | 1999-12-31 | 261d? | start no earlier than 1999-01-01 | N1 | 2088h | 2088h | DTMF | R99 | Frederic | DTMF | 23.014 CR#0004 | NP-06 |  |  |
| 8688 | 2570 | Deleted - Intersystem_Change |  | 261d? | 1999-01-01 A | 1999-12-31 A | 100% | 1999-01-01 | 1999-12-31 | 261d? | start no earlier than 1999-01-01 | SMG | 2088h | 2088h | Intersystem_Change | R99 |  | Intersystem_Change | 04.18 CR#A243 | SMG |  |  |
| 8689 | 2571 | Deleted - Long_Forwardedto_Numbers |  | 261d? | 1999-01-01 A | 1999-12-31 A | 100% | 1999-01-01 | 1999-12-31 | 261d? | start no earlier than 1999-01-01 | N2 | 2088h | 2088h | Long_Forwardedto_Numbers | R99 | Kimmo | Long_Forwardedto_Numbers | 29.002 | NP-06 |  |  |
| 8690 | 2572 | Deleted - RANimp-FSEarlyUE |  | 261d? | 1999-01-01 A | 1999-12-31 A | 100% | 1999-01-01 | 1999-12-31 | 261d? | start no earlier than 1999-01-01 | R3 | 2088h | 2088h | RANimp-FSEarlyUE | R99 | Juha | RANimp-FSEarlyUE | 25.413 CR#0520; 0538; 0565; 0563; 0541; 0540; 0539; 0547 | RP-06 |  |  |
| 8691 | 2573 | Release 1999 Studies |  | 261d? | 1999-01-01 A | 1999-12-31 A | 100% | 1999-01-01 | 1999-12-31 | 261d? |  | S1; T2 | 4176h | 4176h |  | R99 | Alain |  |  |  |  |  |
| 8692 | 2574 | Advanced Addressing/Numbering |  | 261d? | 1999-01-01 A | 1999-12-31 A | 100% | 1999-01-01 | 1999-12-31 | 261d? | start no earlier than 1999-01-01 | S1 | 2088h | 2088h | Numbering | R99 | Alain | Numbering | 22.975 |  | Vodafone | mona.mustapha@vodafone.com |
| 8693 | 2575 | Combined GSM and Mobile IP mobility handling in UMTS IP CN |  | 261d? | 1999-01-01 A | 1999-12-31 A | 100% | 1999-01-01 | 1999-12-31 | 261d? | start no earlier than 1999-01-01 | S2 | 2088h | 2088h |  | R99 | Maurice |  | 23.923 |  |  |  |
| 8694 | 2576 | UE Capabilities Requirements |  | 261d? | 1999-01-01 A | 1999-12-31 A | 100% | 1999-01-01 | 1999-12-31 | 261d? | start no earlier than 1999-01-01 | T2 | 2088h | 2088h | UCR | R99 |  | UCR | 21.904 |  |  |  |
| 8695 | 2577 | Electrical safety requirements and regulations |  | 261d? | 1999-01-01 A | 1999-12-31 A | 100% | 1999-01-01 | 1999-12-31 | 261d? | start no earlier than 1999-01-01 | T2 | 2088h | 2088h |  | R99 |  |  | 34.907 |  |  |  |
| 8696 | 2578 | Specific Absorbtion Rate (SAR) requirements and regulations in different regions |  | 261d? | 1999-01-01 A | 1999-12-31 A | 100% | 1999-01-01 | 1999-12-31 | 261d? | start no earlier than 1999-01-01 | T2 | 2088h | 2088h |  | R99 |  |  | 34.925 |  |  |  |
| 8697 | 2579 | Multi-mode UE issues |  | 261d? | 1999-01-01 A | 1999-12-31 A | 100% | 1999-01-01 | 1999-12-31 | 261d? | start no earlier than 1999-01-01 | T2 | 2088h | 2088h |  | R99 |  |  | 21.810; 21.910 |  |  |  |
| 8698 | 2580 | Provision of fax service in GSM and UMTS |  | 261d? | 1999-01-01 A | 1999-12-31 A | 100% | 1999-01-01 | 1999-12-31 | 261d? | start no earlier than 1999-01-01 | T2 | 2088h | 2088h |  | R99 |  |  | 22.945 |  | Ericsson | peter.bleckert@ericsson.com |
| 8699 | 2581 | Separating Radio Resources and Mobility Management specific parts of the MS Classmark |  | 261d | 1999-01-01 A | 1999-12-31 A | 100% | 1999-01-01 | 1999-12-31 | 261d |  | T2 | 2088h | 2088h |  | R99 |  |  | 23.814 |  |  |  |

Notes:
- 8676: -
- 8677: -
- 8678: -
- 8679: Specifies Conformance Tests for a 3G UE to be recognised as 3GPP-standard compliant. A 3GPP-external body, GCF (Global Certification Forum), delivers certificates to prove that a UE has correctly passed tests and is then conform to the 3GPP standard.
- 8680: No CR or new TS/TR approved under this WI
- 8681: -
- 8682: measurement procedures for the conformance test of the UE that contain transmitting characteristics, receiving characteristics and performance requirements in addition to requirements for support of RRM (Radio Resource Management) in FDD mode.
- 8683: measurement procedures for the conformance test of the UE that contain transmitting characteristics, receiving characteristics and performance requirements in addition to requirements for support of RRM (Radio Resource Management) in TDD mode.
- 8684: TS 34.123, composed of three parts, actually specifies the protocol conformance testing for the 3G UE. Part 1 describes the overall test structure.
- 8685: Part 2 contains the applicability of each test case defined as the Implementation Conformance Statement (ICS) proforma, in compliance with the relevant requirements, and in accordance with the relevant guidance given in ISO/IEC 9646-7 and ETS 300 406.
- 8686: Part 3 specifies the protocol conformance testing in TTCN for the 3G UE at the Uu interface. It defines the TTCN test specification and design considerations in Abstract Test Suites based on the test cases specified in prose in part 1.
- 8687: No CR or new TS/TR approved under this WI
- 8688: No CR or new TS/TR approved under this WI
- 8689: -
- 8690: No CR or new TS/TR approved under this WI
- 8691: -
- 8692: Study on requirements for numbering and addressing for UMTS
- 8693: -
- 8694: Moved to CT1 at TSG-T closure
- 8695: Moved to RAN4 at TSG-T closure. TR summarizes differences between international and national standards relevant to IEC60950 and refers to regulations for conformity assessment due to different regulatory environments in different countries / regions.
- 8696: Moved to RAN4 at TSG-T closure.
- 8697: Moved to CT1 at TSG-T closure. Consequences on roaming capabilities and service availability (e.g. handover) of multi-mode UEs while roaming in various regions with various network configurations. Case studies for each of the possible scenarios in specs
- 8698: CP#27: Moved to C1 on closure of T2¦see TP-050062. CP#28: C1->C3
- 8699: CP#27: change of WG as a result of closure of CN and T.
